# COSTED BL14-001 12 GeV CR13-015,14-001

Schedule from Primavera P6, 2004-03-31 to 2017-09-29, data date 2006-09-30, costs in USD, A marks actual dates.
CHANGE REQUESTS INCLUDED / FY07 002, 003, 006, 007, 008, 010, 005, 009, 014, 012, 15, / 17, 18, 19, 20, 21, 22, 24, 25, 26, 27, 29-33 / FY08 001, 002, 003, 005, 004, 011, 014, 013, 009, 016, 018, / 006, 017, 019, 020, 024(N/C), 023, 010, 025, 021, 022 , 027, 028, / 031, 029, 030(NC), 032, 033, 034, 035, 036, 037, 038, 039, 042, 044, 043, 041, / 045, 046, 048, 048, 049, 051, 050, 052, 054, 055, 056, 057, / 09-001 , 08-058, 059, 060 / FY09 003, 002, 004, 005, 007, 008, 009, 010, 011, 012, / 14A-G,16,17,15,23,9A, 10A, 26, 22, 2431,35,34,33, 32, 27,28,36, 30, 37, / 38,45,43,40,46,41,47,48,43A,44,49,52,39,42,53 / FY10 001A-B, E, 002, / 005,003,004,008,007,010,011,12,18,23,12A,35,36,22,32,33,34,20,21,29,37,24,26,009,019,25,30,27,41,38,40,43,39,44,16,45,28,31,14,50,51,46,48,52,53,54,56,55,42,57,47,17,15,62,59,58,64,66 / ,61,71,70,67,63,VA1,60,65,69 / FY11 / 001-A&D,10-074,004,VA-001,002,007,003,010,016,011,014,15,19,09,17,18,12,13,20,06,08,22,23,VA2,VA3,26,24,27,31,28,30,29,38,25,32,37,46,47,35,40,43,42,44,41,22a,49,52,51,005,48,39,36,55,57,54 / FY12 001-A&D, / 005,002,003,007,010,009,011,008,012,014,015,016,17,13,22,25,18,23,21,26,24,29,28,27,29A,34,37,38,35,36,32,39,42,44,45,43,50,46,47,53,51,54,49,55,40 / FY13 001D,003,008,009,002,004,005,012,006,011,14,15,16 / FY14 001 / This project is to be used to develop the new DOE guidance schedule / Mark Wiseman's PED corrections have been made - RKC
Must finish by 2017-09-30

## Calendars

- 8/5 M-F w/JLAB Holidays STANDARD: Mon-Fri 08:00-16:00; Sat-Sun off. Exceptions (off unless hours are given): 2004-05-31, 2004-07-05, 2004-09-06, 2004-11-25 to 2004-11-26, 2004-12-24, 2004-12-27 to 2004-12-31, 2005-01-17, 2005-02-14, 2005-05-30, 2005-07-04, 2005-09-05, 2005-11-24 to 2005-11-25, 2005-12-26 to 2005-12-30, 2006-01-02, 2006-01-16, 2006-02-20, 2006-05-29, 2006-07-04, 2006-09-04, 2006-11-23 to 2006-11-24, 2006-12-25 to 2006-12-29, 2007-01-01, 2007-01-15, 2007-02-19, 2007-05-28, 2007-07-04, 2007-09-03, 2007-11-22 to 2007-11-23, 2007-12-24 to 2007-12-28, 2007-12-31 to 2008-01-01, 2008-01-21, 2008-02-18, 2008-05-26, 2008-07-04, 2008-09-01, 2008-11-27 to 2008-11-28, 2008-12-25 to 2008-12-26, 2008-12-29 to 2009-01-01, 2009-01-19, 2009-02-16, 2009-05-25, 2009-07-03, 2009-09-07, 2009-11-26 to 2009-11-27, 2009-12-21 to 2009-12-25, 2010-01-01, 2010-01-18, 2010-02-15, 2010-05-31, 2010-07-05, 2010-09-06, 2010-11-25 to 2010-11-26, 2010-12-22 to 2010-12-24, 2010-12-27 to 2010-12-28, 2011-01-03, 2011-01-17, 2011-02-21, 2011-05-30, 2011-07-04, 2011-09-05, 2011-11-24 to 2011-11-25, 2011-12-22 to 2011-12-23, 2011-12-26 to 2011-12-28, 2012-01-02, 2012-01-16, 2012-02-20, 2012-05-28, 2012-06-04, 2012-09-03, 2012-11-22 to 2012-11-23, 2012-12-24 to 2012-12-28, 2013-01-01, 2013-01-21, 2013-02-18, 2013-05-27, 2013-07-04, 2013-09-02, 2013-11-28 to 2013-11-29, 2013-12-23 to 2013-12-27, 2014-01-01, 2014-01-20, 2014-02-17, 2014-05-26, 2014-07-04, 2014-09-01, 2014-11-27 to 2014-11-28, 2014-12-22 to 2014-12-26, 2015-01-01, 2015-01-20, 2015-02-24, 2015-06-01, 2015-07-03, 2015-07-06, 2015-09-07, 2015-11-26 to 2015-11-27, 2015-12-24 to 2015-12-25, 2015-12-28 to 2016-01-01, 2016-01-18, 2016-02-15, 2016-05-30, 2016-07-04, 2016-09-05, 2016-11-24 to 2016-11-25, 2016-12-26 to 2016-12-30, 2017-01-02, 2017-01-16, 2017-02-20, 2017-05-29, 2017-07-04, 2017-09-04.
- 8/5 M-F w/JLAB Holidays ReBaseline: Mon-Fri 08:00-16:00; Sat-Sun off. Exceptions (off unless hours are given): 2004-05-31, 2004-07-05, 2004-09-06, 2004-11-25 to 2004-11-26, 2004-12-24, 2004-12-27 to 2004-12-31, 2005-01-17, 2005-02-14, 2005-05-30, 2005-07-04, 2005-09-05, 2005-11-24 to 2005-11-25, 2005-12-26 to 2005-12-30, 2006-01-02, 2006-01-16, 2006-02-20, 2006-05-29, 2006-07-04, 2006-09-04, 2006-11-23 to 2006-11-24, 2006-12-25 to 2006-12-29, 2007-01-01, 2007-01-15, 2007-02-19, 2007-05-28, 2007-07-04, 2007-09-03, 2007-11-22 to 2007-11-23, 2007-12-24 to 2007-12-28, 2007-12-31 to 2008-01-01, 2008-01-21, 2008-02-18, 2008-05-26, 2008-07-04, 2008-09-01, 2008-11-27 to 2008-11-28, 2008-12-25 to 2008-12-26, 2008-12-29 to 2009-01-01, 2009-01-19, 2009-02-16, 2009-05-25, 2009-07-03, 2009-09-07, 2009-11-26 to 2009-11-27, 2009-12-21 to 2009-12-25, 2010-01-01, 2010-01-18, 2010-02-15, 2010-05-31, 2010-07-05, 2010-09-06, 2010-11-25 to 2010-11-26, 2010-12-22 to 2010-12-24, 2010-12-27 to 2010-12-28, 2011-01-03, 2011-01-17, 2011-02-21, 2011-05-30, 2011-07-04, 2011-09-05, 2011-11-24 to 2011-11-25, 2011-12-22 to 2011-12-23, 2011-12-26 to 2011-12-28, 2012-01-02, 2012-01-16, 2012-02-20, 2012-05-28, 2012-06-04, 2012-09-03, 2012-11-22 to 2012-11-23, 2012-12-24 to 2012-12-28, 2013-01-01, 2013-01-21, 2013-02-18, 2013-05-27, 2013-07-04, 2013-09-02, 2013-11-28 to 2013-11-29, 2013-12-23 to 2013-12-27, 2013-12-30 to 2014-01-01, 2014-01-20, 2014-05-26, 2014-07-04, 2014-09-01, 2014-11-27 to 2014-11-28, 2014-12-24 to 2014-12-26, 2014-12-29 to 2015-01-02, 2015-01-19, 2015-05-25, 2015-06-01, 2015-07-03, 2015-09-07, 2015-11-26 to 2015-11-27, 2015-12-24 to 2015-12-25, 2015-12-28 to 2016-01-01, 2016-01-18, 2016-05-30, 2016-07-04, 2016-09-05, 2016-11-24 to 2016-11-25, 2016-12-23, 2016-12-26 to 2016-12-30, 2017-01-02, 2017-01-16, 2017-05-29, 2017-07-04, 2017-09-04.

## Resources

| Resource | Group | Unit | Rate | Notes |
| --- | --- | --- | --- | --- |
| SUPPLIES & MATERIALS | equipment |  |  |  |
| PROCUREMENT<$50K 60 NO ESCALATION | material | unit |  |  |
| PROCUREMENT>$50K 69 NO ESCALATION | material | unit |  |  |
| PROCUREMENT<$50K 60 NO ESCALATION FY11 | material | unit |  |  |
| PROCUREMENT>$50K 69 NO ESCALATION FY11 | material | unit |  |  |
| PROCUREMENT<$50K 60 | material | unit |  |  |
| PROCUREMENT>$50K 69 | material | unit |  |  |
| MECH TECH | labor |  | 47.32 |  |
| ELEC TECH | labor |  | 46.99 |  |
| MECH DES | labor |  | 51.3 |  |
| OFFICE | labor |  | 30.4 | Carolyn Camp |
| ELEC ENG | labor |  | 75.13 |  |
| MECH ENG | labor |  | 74.67 |  |
| PLANT ENG | labor |  | 74.79 |  |
| SCIENTIST | labor |  | 75.18 |  |
| PROCUREMENT<$50K 60 NO ESCALATION FY12 | material | unit |  |  |
| PROCUREMENT>$50K 69 NO ESCALATION FY10 | material | unit |  |  |
| PROCUREMENT>$50K 69 NO ESCALATION FY12 | material | unit |  |  |
| PROCUREMENT<$50K 60 NO ESCALATION FY14 | material | unit |  |  |
| PROCUREMENT>$50K 69 NO ESCALATION FY14 | material | unit |  |  |
| SR STAFF | labor |  | 120.32 | Robert Rimmer, / Larry Phillips, / Charlie Reece, / Joe Preble, / Peter Kneisel, / Jacek Sekutowicz / (1/2) |
| DIRECTORATE | labor |  | 203.37 |  |
| ADMIN | labor |  | 62.54 |  |
| COMP SCIENT | labor |  | 69.87 |  |
| ELEC DES | labor |  | 53.78 |  |
| CONTRB UNIV LBR | labor |  |  |  |
| VISTNG USERS | labor |  | 20.59 |  |
| PD UNIV STUDNT | labor |  | 11.36 |  |
| PLABOR | equipment |  |  |  |
| PROCUREMENT<$50K 60 NO ESCALATION FY13 | material | unit |  |  |
| TRAVEL | equipment |  |  |  |
| PROCUREMENT<$50K 60 NO ESCALATION FY10 | material | unit |  |  |
| PROCUREMENT>$50K 69 NO ESCALATION FY13 | material | unit |  |  |
| PD UNIV STAFF | labor |  | 59.83 |  |
| PLABOR | equipment |  |  |  |
| SKLLD TRADE | labor |  | 35.62 |  |
| MSHOP | equipment |  |  |  |
| PLABOR | equipment |  |  |  |
| PLABOR | equipment |  |  |  |
| PROCUREMENT<$50K 60 NO ESCALATION FY15 | material | unit |  |  |
| PROCUREMENT>$50K 69 NO ESCALATION FY15 | material | unit |  |  |
| PLABOR | equipment |  |  |  |
| EXPENSES >$50 69 | equipment |  |  |  |
| PROCUREMENT<$50K 60 NO ESCALATION FY08 | material | unit |  |  |
| PROCUREMENT>$50K 69 NO ESCALATION FY09 | material | unit |  |  |
| PROCUREMENT<$50K 60 NO ESCALATION FY09 | material | unit |  |  |
| SCIENTIST | labor |  | 72.86 | Haipeng Wang, / Mircea Stirbet, / Frank Marhauser |
| ELEC TECH | labor |  | 45.54 | Will Sommer, / Danny Forehand, / Jim Gordon, / Roland / Overton |
| MECH ENG | labor |  | 72.36 |  |
| MECH DES | labor |  | 49.71 | Larry Turlington |
| MECH ENG | labor |  | 72.36 |  |
| MECH ENG | labor |  | 72.36 |  |
| MECH TECH | labor |  | 45.86 | Jeff / Campbell, / Mike McC rea, / Ken Worland, / Leonard Page, / Scott Williams, / Steven / Castagnola, / Chris Dreyfus |
| MECH TECH | labor |  | 45.86 | Frank Humphry, / Dave Bigelow, / Scott / Williams |
| MECH TECH | labor |  | 45.86 |  |
| MECH ENG | labor |  | 72.36 | Jeffrey Saunders |
| MECH TECH | labor |  | 45.86 | James Davenport / , / George Dekerlegand, / Bryon Golden, / Tina / Harris, / Isiah / Daniels |
| MECH DES | labor |  | 49.71 |  |
| ELEC TECH | labor |  | 45.54 | Thomas Goodman, / Henry Whitehead, / Derek / Dale, / Steve / Dutton, / Larry King |
| ELEC ENG | labor |  | 72.81 | Kirk Davis, / Mike Drury |
| MECH ENG | labor |  | 72.36 | Brian Carpenter |
| MECH ENG | labor |  | 72.36 | Steve / Manning, / Rich Bundy |
| PLABOR | equipment |  |  |  |
| PROCUREMENT>$50K 69 NO ESCALATION FY08 | material | unit |  |  |
| SCIENTIST | labor |  | 72.86 |  |
| PLABOR | equipment |  |  |  |
| SCIENTIST | labor |  | 72.86 |  |
| MECH ENG | labor |  | 72.36 |  |
| MECH DES | labor |  | 49.71 |  |

## Schedule

| ID | WBS | Activity | Type | Duration | Start | Finish | Predecessors | Complete | Total float | Free float | Constraint | Calendar | Planned FinishUDF | GROP Group | RESP - Responsibility | MILE - Milestone | STRT%COMP for CM EVM | FNSH%COMP for CM EVM | Milestone Level | CAM RESPONSIBLE | PPEP Date | 12 GeV 1st level Critical Path | CIVIL CRITICAL MILESTONES | Profile change | 12 GeV 5th level Critical Path | Post Rebaseline | CR 09-023 | CR 10-028 | CR 10-064 | CR 10-066 | CR 11-015 | CR 12-018 | CR 10-065 | CR 12-029 | CR 12-050 | CR 11-026 | CR 12-025 | CR 09-030 Repair | CR 09-028 | CR 09-028 Repair | EVMS Reporting Codes | CR 08-048 | CR 09-022 | CR 09-041 | CR 10-067 | CR 10-069 | CR 11-046 | CR 12-003 | CR 12-012 | CR 12-036 | CR 10-063 | CR 10-074 | CR 11-017 | CR 11-025 | CR 11-035 | CR 12-024 | CR 13-002 | CR 10-008 | CR 10-076 | CR 12-054 | Original Activity ID Rebaseline | Inter Project Link (IPL) | CR 13-006 | CR 13-010 |
| --- | --- | --- | --- | --- | --- | --- | --- | --- | --- | --- | --- | --- | --- | --- | --- | --- | --- | --- | --- | --- | --- | --- | --- | --- | --- | --- | --- | --- | --- | --- | --- | --- | --- | --- | --- | --- | --- | --- | --- | --- | --- | --- | --- | --- | --- | --- | --- | --- | --- | --- | --- | --- | --- | --- | --- | --- | --- | --- | --- | --- | --- | --- | --- | --- |
|  | 0M | **1.M MILESTONES** |  |  | 2004-03-31 | 2017-09-29 |  |  |  |  |  |  |  |  |  |  |  |  |  |  |  |  |  |  |  |  |  |  |  |  |  |  |  |  |  |  |  |  |  |  |  |  |  |  |  |  |  |  |  |  |  |  |  |  |  |  |  |  |  |  |  |  |  |  |
|  | 1.01M | **1.01 LEVEL 1 MILESTONES** |  |  | 2004-03-31 | 2017-09-29 |  |  |  |  |  |  |  |  |  |  |  |  |  |  |  |  |  |  |  |  |  |  |  |  |  |  |  |  |  |  |  |  |  |  |  |  |  |  |  |  |  |  |  |  |  |  |  |  |  |  |  |  |  |  |  |  |  |  |
| 1-1M |  | CD-0 (Approve Mission Need) | milestone | 0d | 2004-03-31 A | 2004-03-31 A |  | 100% |  |  |  |  | 2004-03-31 | CDS | DOE | 0 | 1 | 1 | 1 | CLAUS R |  |  |  |  |  |  |  |  |  |  |  |  |  |  |  |  |  |  |  |  |  |  |  |  |  |  |  |  |  |  |  |  |  |  |  |  |  |  |  |  |  |  |  |  |
| 1-2M |  | CD-1 (Approve Preliminary Baseline Range) | milestone | 0d | 2006-02-15 A | 2006-02-15 A | 1-1M FS+399d | 100% |  |  | finish on or after 2005-09-30 |  | 2006-02-15 | CDS | DOE | 0 | 1 | 1 | 1 | CLAUS R |  |  |  |  |  |  |  |  |  |  |  |  |  |  |  |  |  |  |  |  |  |  |  |  |  |  |  |  |  |  |  |  |  |  |  |  |  |  |  |  |  |  |  |  |
| 1-5M |  | CD-2 (Approve Performance Baseline) | milestone | 0d | 2008-01-02 | 2008-01-02 | 121224030, 121223030, 1241176M, 1241056M, 1241016M, 121224022, 123221007ALOE, 1241096M, 3R-3M, 1241136M, 121221055 |  | 0d |  | mandatory finish 2007-12-28 |  | 2007-09-28 | CDS | DOE | 0 | 1 | 1 | 1 | CLAUS R |  |  |  |  |  |  |  |  |  |  |  |  |  |  |  |  |  |  |  |  |  |  |  |  |  |  |  |  |  |  |  |  |  |  |  |  |  |  |  |  |  |  |  |  |
| 1-6M |  | CD-3 (Approve Start of Constr) | milestone | 0d | 2008-09-30 | 2008-09-30 | 1142030, 3R-05M, 117908LOE, 3R-08M, 122311908LOE, 1212112908LOE, 1211005M5, 1152945LOE, 123221025, 1212111120, 122312070 FS-40d, 1212111908LOE |  | 0d |  | mandatory finish 2008-09-30 |  |  | CDS | DOE | 0 | 1 | 1 | 1 | CLAUS R | 2008-09-30 | 1 | CVL | C | 5 |  |  |  |  |  |  |  |  |  |  |  |  |  |  |  |  |  |  |  |  |  |  |  |  |  |  |  |  |  |  |  |  |  |  |  |  |  |  |  |
| 1-7M |  | CD-4A ( Approve Accelerator Completion & Start of Operations) | milestone | 0d | 2014-12-23 | 2014-12-23 | 2-S10M, 2-S01M, 2-S02M, 23221023Da, 23641914LOE, 2-S09M, 2-S03M, 2-S11M, 2-S05M, 2-S06M, 13421050M, 23221140LOEa, 23221023Ga, 2-S04M, 281315030, 281315030a, 23642914LOE, 23643914LOE, 28000, 2-S07M, 3C-13M, 23224087, 23224087a, 2-S08M, 3A-59M |  | 0d |  | mandatory finish 2014-12-23 | 8/5 M-F w/JLAB Holidays ReBaseline |  |  | DOE |  | 1 | 1 | 1 | CLAUS R |  |  |  | C |  | PR |  |  |  |  |  |  |  |  |  |  |  |  |  |  |  |  |  |  |  |  |  |  |  |  |  |  |  |  |  |  |  |  |  |  |  |  |  |  |
| 1-8M |  | CD-4B (Approve Proj Compltn & Start of Operations) | milestone | 0d | 2017-09-29 | 2017-09-29 | 2-08M, 1-7M, 28005, 2831916LOE, 28010, 28025, 28015, 2-06M, 28020 |  | 0d |  | mandatory finish 2017-09-29 | 8/5 M-F w/JLAB Holidays ReBaseline |  | CDS | DOE | 0 | 1 | 1 | 1 | CLAUS R |  | 1 |  | C |  | PR |  |  |  |  |  |  |  |  |  |  |  |  |  |  |  |  |  |  |  |  |  |  |  |  |  |  |  |  |  |  |  |  |  |  |  |  |  |  |
|  | 1.02A | **1.02A LEVEL 2 ACCELERATOR MILESTONES** |  |  | 2010-07-14 | 2014-06-25 |  |  |  |  |  |  |  |  |  |  |  |  |  |  |  |  |  |  |  |  |  |  |  |  |  |  |  |  |  |  |  |  |  |  |  |  |  |  |  |  |  |  |  |  |  |  |  |  |  |  |  |  |  |  |  |  |  |  |
| 2-01M |  | Klystron Mass Production Authorization | milestone | 0d | 2010-07-14 | 2010-07-14 | 132111049 |  | 154d | 0d | start on or before 2011-06-30 |  |  |  | RODE C |  | 1 | 1 | 2 | CLAUS R |  |  |  |  |  |  | 09-023 | 10-028 | 10-064 | 10-066 | 11-015 | 12-018F |  |  |  |  |  |  |  |  |  |  |  |  |  |  |  |  |  |  |  |  |  |  |  |  |  |  |  |  |  |  |  |  |
| 2-02M |  | Start Accelerator Installation Shutdown (IPL) | milestone | 0d | 2012-05-14 | 2012-05-14 | 13445005, 13421030a, 1317015, 13411200a, 13411140a, 13416049B, 13456030M FS+130d, 13454040 FS-50d, 13446010b, 13435010, 13454047, 13444015, 13432015, 13411070M, 13416049A, 13416035M, 13444025, 13444020, 13411145, 13414055, 13456022LOEa, 13434005a, 13411196, 13414030M FS-175d, 13414095M FS-99d, 13425030, 13456029, 13451095, 13441010, 13433005, 13421070M, 13456042, 13456047 FS-40d, 13451100a, 13451105a, 13417015 |  | 0d |  | mandatory start 2012-05-14 |  |  |  | RODE C |  | 1 | 1 | 2 | CLAUS R | 2010-12-31 |  |  |  |  |  |  |  |  |  |  |  |  |  |  |  |  |  |  |  |  |  |  |  |  |  |  |  |  |  |  |  |  |  |  |  |  |  |  |  |  |  |  |  |
| 2-26M |  | Accel Installtn Comptd Except for All Power Supplies | milestone | 0d | 2013-10-29 | 2013-10-29 | 4A-07M, 4A-09M, 4A-08M |  | 22d |  |  | 8/5 M-F w/JLAB Holidays ReBaseline |  | CVL | HARWOOD L | 4 | 1 | 1 | 3 | LEIGH H |  |  |  |  |  | PR |  |  |  |  |  | 12-018 | 10-065 | 12-029 | 12-050 |  |  |  |  |  |  |  |  |  |  |  |  |  |  |  |  |  |  |  |  |  |  |  |  |  |  |  |  |  |
| 2-03M |  | Accelerator Commissioned | milestone | 0d | 2013-12-20 | 2013-12-20 | 2812005, 2811005 |  | 0d |  | finish on or before 2013-12-31 | 8/5 M-F w/JLAB Holidays ReBaseline |  |  | RODE C |  | 1 | 1 | 2 | CLAUS R | 2012-03-30 |  |  |  |  | PR |  |  |  |  |  |  |  | 12-029F |  | 11-026 | 12-025 |  |  |  |  |  |  |  |  |  |  |  |  |  |  |  |  |  |  |  |  |  |  |  |  |  |  |  |
| 2-25M |  | Box Supply Installtn Comptd | milestone | 0d | 2014-06-25 | 2014-06-25 | 13222100, 13222035, 23222230a, 2813224000a, 13222230, 23222230, 23222195, 23221022c, 2813221000a, 13222100A, 13222195, 2813221000, 23222142, 13222067, 13221025 FS-2d, 2813224000, 23222035, 23222067a, 13222065, 13222140, 13222160, 23222100A, 13222142, 13221025A, 23222035a, 23222195a |  | 0d |  |  | 8/5 M-F w/JLAB Holidays ReBaseline |  | ACCL | HARWOOD L | 4 | 1 | 1 | 3 | LEIGH H |  |  |  |  |  | PR |  | 10-028 |  |  |  |  |  | 12-029 | 12-050 |  |  |  |  |  |  |  |  |  |  |  |  |  |  |  |  |  |  |  |  |  |  |  |  |  |  |  |  |  |
|  | 1.02H | **1.02H LEVEL 2 HALLS A, B & C MILESTONES** |  |  | 2006-10-02 | 2016-02-10 |  |  |  |  |  |  |  |  |  |  |  |  |  |  |  |  |  |  |  |  |  |  |  |  |  |  |  |  |  |  |  |  |  |  |  |  |  |  |  |  |  |  |  |  |  |  |  |  |  |  |  |  |  |  |  |  |  |  |
| 2-04M |  | Design Report on Superconducting Magnets | milestone | 0d | 2006-10-02 | 2006-10-02 |  |  | 247d | 1734d | finish on or before 2007-09-28 |  |  |  | RODE C |  | 1 | 1 | 2 | CLAUS R | 2007-09-28 |  |  |  |  |  |  |  |  |  |  |  |  |  |  |  |  |  |  |  |  |  |  |  |  |  |  |  |  |  |  |  |  |  |  |  |  |  |  |  |  |  |  |  |
| 2-05M |  | Design Review on Superconducting Magnets | milestone | 0d | 2008-05-30 | 2008-05-30 | 12221060M, 122311045M, 122312080, 122312050M, 12221045M |  | 43d |  | finish on or before 2008-07-31 |  |  |  | RODE C |  | 1 | 1 | 2 | CLAUS R | 2008-03-31 |  |  | C | 5 |  |  |  |  |  |  |  |  |  |  |  |  |  |  |  |  |  |  |  |  |  |  |  |  |  |  |  |  |  |  |  |  |  |  |  |  |  |  |  |
| 2-06M |  | Award First Superconducting Magnet Contract | milestone | 0d | 2009-03-16 | 2009-03-16 | 3R-05M, 14312000M |  | 98d | 2121d | finish on or before 2009-07-31 |  |  |  | RODE C |  | 1 | 1 | 2 | CLAUS R | 2009-03-31 |  |  |  |  |  |  |  |  |  |  |  |  |  |  |  |  |  |  |  |  |  |  |  |  |  |  |  |  |  |  |  |  |  |  |  |  |  |  |  |  |  |  |  |
| 2-07M |  | Start Installation for Existing Halls | milestone | 0d | 2012-05-14 | 2012-05-14 | 2-02M, 14368010M |  | 54d | 0d | start on or before 2012-07-31 |  |  |  | RODE C |  | 1 | 1 | 2 | CLAUS R | 2011-03-31 |  |  |  |  |  |  |  |  |  |  |  |  |  |  |  |  | 09-030 |  |  |  |  |  |  |  |  |  |  |  |  |  |  |  |  |  |  |  |  |  |  |  |  |  |  |
| 2-08M |  | Installation of Experimental Equipment into H-A is Completed | milestone | 0d | 2013-10-11 | 2013-10-11 | 14132020, 3A-43M, 14153020, 24153020, 14151010a, 24152025, 14152025 |  | 48d | 0d | finish on or before 2013-12-31 | 8/5 M-F w/JLAB Holidays ReBaseline |  |  | RODE C |  | 1 | 1 | 2 | CLAUS R | 2013-03-29 |  |  |  |  | PR |  |  |  |  |  |  |  |  |  |  | 12-025 |  |  |  |  |  |  |  |  |  |  |  |  |  |  |  |  |  |  |  |  |  |  |  |  |  |  |  |
| 2-09M |  | Hall-A Beam Commissioning Completed | milestone | 0d | 2014-03-05 | 2014-03-05 | 2811020, 2812065, 2821X000 |  | 18d | 0d | finish on or before 2014-03-31 | 8/5 M-F w/JLAB Holidays ReBaseline |  |  | RODE C |  | 1 | 1 | 2 | CLAUS R |  |  |  |  |  | PR |  |  |  |  |  |  |  |  |  | 11-026 | 12-025 |  | 09-028 | 09-028 |  |  |  |  |  |  |  |  |  |  |  |  |  |  |  |  |  |  |  |  |  |  |  |  |
| 2-27M |  | Hall C Q1 Magnet Delivered | milestone | 0d | 2014-06-30 | 2014-06-30 | 24312053M |  | 87d | 0d | finish on or before 2014-10-31 | 8/5 M-F w/JLAB Holidays ReBaseline |  |  | FENKER H |  | 1 | 1 |  | HOWARD F |  |  |  |  |  | PR |  |  |  |  |  |  |  |  |  | 11-026 |  |  |  |  | M | 08-048 | 09-022 | 09-041 | 10-067 | 10-069 | 11-046 | 12-003 | 12-012 | 12-036 |  |  |  |  |  |  |  |  |  |  |  |  |  |  |
| 2-28M |  | Hall C HB Magnet Delivered | milestone | 0d | 2014-07-23 | 2014-07-23 | 24311160 FS-7d |  | 49d | 29d | finish on or before 2014-09-30 | 8/5 M-F w/JLAB Holidays ReBaseline |  |  | FENKER H |  | 1 | 1 |  | HOWARD F |  |  |  |  |  | PR |  |  |  |  |  |  |  |  |  | 11-026 |  |  |  |  | M | 08-048 | 09-022 |  |  | 10-069 | 11-046 |  | 12-012 | 12-036 | 10-063 | 10-074 | 11-017 | 11-025 |  |  |  |  |  |  |  |  |  |  |
| 2-34M |  | Hall B Torus Cold Mass Delivered | milestone | 0d | 2014-09-30 | 2014-09-30 | 14271012, 14273005, 14271020, 14271000, 24271740M, 14273000 |  | 0d |  | finish on or before 2014-09-30 | 8/5 M-F w/JLAB Holidays ReBaseline |  |  | ELOUADRHIRI L |  | 1 | 1 |  | LATIFA E |  |  |  |  |  | PR |  |  |  |  |  |  |  |  |  | 11-026 |  |  |  |  | M | 08-048 |  |  |  |  |  |  |  |  |  |  |  |  | 11 -035 | 12-024 | 13-002F |  |  |  |  |  |  |  |
| 2-35M |  | Hall B Solenoid Cryostated Coil Delivered | milestone | 0d | 2014-11-26 | 2014-11-26 | 14271080, 242781005LOE, 24272075k, 24272075n |  | 17d | 0d | finish on or before 2014-12-31 | 8/5 M-F w/JLAB Holidays ReBaseline |  |  | ELOUADRHIRI L |  | 1 | 1 |  | LATIFA E |  |  |  |  |  | PR |  |  |  |  |  |  |  |  |  | 11-026 |  |  |  |  | M | 08-048 |  |  |  |  |  |  |  |  |  |  |  |  | 11 -035 | 12-024 | 13-002F |  |  |  |  |  |  |  |
| 2-29M |  | Hall C Dipole Delivered | milestone | 0d | 2015-05-18 | 2015-05-18 | 24314030a |  | 0d |  | finish on or before 2015-06-30 | 8/5 M-F w/JLAB Holidays ReBaseline |  |  | FENKER H |  | 1 | 1 |  | HOWARD F |  |  |  |  |  | PR |  |  |  |  |  |  |  |  |  | 11-026 |  |  |  |  | M | 08-048 | 09-022 |  |  | 10-069 | 11-046 |  | 12-012 | 12-036 |  |  | 11-017 |  |  |  |  | 10-008 | 10-076 |  |  |  |  |  |
| 2-30M |  | Hall C Q2 Magnet Delivered | milestone | 0d | 2015-06-19 | 2015-06-19 | 24313019a FS-72d |  | 18d | 12d | finish on or before 2015-07-31 | 8/5 M-F w/JLAB Holidays ReBaseline |  |  | FENKER H |  | 1 | 1 |  | HOWARD F |  |  |  |  |  | PR |  |  |  |  |  |  |  |  |  | 11-026 |  |  |  |  | M | 08-048 | 09-022 |  |  | 10-069 | 11-046 |  | 12-012 | 12-036 |  |  | 11-017 |  |  |  |  | 10-008 |  |  |  |  |  |  |
| 2-31M |  | Hall C Q3 Magnet Delivered | milestone | 0d | 2015-08-26 | 2015-08-26 | 24313019a FS-25d, 14313019a |  | 6d |  | finish on or before 2015-09-30 | 8/5 M-F w/JLAB Holidays ReBaseline |  |  | FENKER H |  | 1 | 1 |  | HOWARD F |  |  |  |  |  | PR |  |  |  |  |  |  |  |  |  | 11-026 |  |  |  |  | M | 08-048 | 09-022 |  |  | 10-069 |  |  | 12-012 | 12-036 |  |  | 11-017 |  |  |  |  | 10-008 |  |  |  |  |  |  |
| 2-36M |  | Installtn of Expermntl Equipmnt into H-B is Comptd | milestone | 0d | 2015-12-18 | 2015-12-18 | 28223040, 24212000 FS-250d, 24211095 FS-250d, 24264065M, 24264360, 24264395, 242742020, 24254005, 14247015, 24273012a, 242711.5010a, 14211051o FS-250d, 24264995, 24264003LOE FS-500d, 14235015, 242711.5010, 24272085 FS-500d, 24273007, 242751435, 14254020, 14254008, 24254105, 14241015, 242742020a, 24211090 FS-250d, 14211080 FS-250d, 24264281, 242211620, 24272075r, 24273012, 242742030, 14254010, 24254070, 24254080, 24243010, 14242060M, 14211040C, 24264860M, 14264235, 24264410, 14264002LOE FS-500d, 14264000dLOE FS-500d, 14271028LOEA, 24271725 LOE, 24271735, 24273022, 242781025, 14251005, 24254115, 24264878, 24264470, 242241457, 14234005, 24271730, 242742025, 242751450, 14254025, 24254050, 24254090, 24242060M, 14244025, 24244035, 242711.5010b, 28223030, 28223025, 24212005 FS-250d, 14212005s FS-250d, 14211025a, 24264006LOE FS-500d, 24264230, 14264360, 242241452, 242223570, 24232025, 242711.5025, 24273017, 242781010LOE FS-500d, 24254020, 24254060, 14252010, 24244030, 14247010, 24247060M, 14264345, 24264440, 14264000bLOE FS-500d, 242241462, 242232685M, 24231000, 24235015, 14254007, 24254040, 24254035, 242742030a, 24264888, 24264345, 14264280, 24264390, 14264410, 14264230, 24264500, 242223575, 24233070M, 24272410, 24272405, 24254000, 14244010, 242751435a |  | 3d | 0d | finish on or before 2015-12-31 | 8/5 M-F w/JLAB Holidays ReBaseline |  |  | YOUNG G |  | 1 | 1 | 3 | YOUNG G |  |  |  |  |  | PR |  |  |  |  |  |  |  |  |  | 11-026 |  |  |  |  | M |  |  |  |  |  |  |  |  |  |  |  |  |  | 11 -035 | 12-024 | 13-002 |  |  |  |  |  |  |  |
| 2-32M |  | Installtn of Expermntl Equipmnt into H-C is Comptd | milestone | 0d | 2015-12-23 | 2015-12-23 | 14362812LOE FS-500d, 24363041, 24363046, 24315090, 14314P4TLOE, 14314P4LOE FS-502d, 143118P3LOE FS-502d, 243118P6LOE FS-500d, 143128P5TLOE, 24312915LOE5 FS-500d, 24315015Bba, 24368540, 24368515, 24314P6LOE FS-500d, 24311170, 24311165, 24313P6LOE5 FS-500d, 14368335M, 24368505, 24315015Bb, 14315050LOEg FS-500d, 24315015Ba, 24311071, 243161000, 143248P1LOE5 FS-500d, 14368425, 24368450 FS-5d, 24368590LOE FS-500d, 243128PC13LOE FS-500d, 243128P6LOE5, 24353010a, 24368565, 24368455, 24368052, 24368475, 14315095 FS-2d, 24314110 FS-500d, 243128PC13LOE5 FS-500d, 24313270M FS-50d, 143238P1LOEb FS-500d, 24368110, 24368570, 24368545, 24362000, 24315007 FS-2d, 24314051M, 24311072a, 24312050d, 24353010, 24315050LOEg FS-500d, 143128PC13LOE, 14353010, 28236030, 24311168, 24312055, 143218P2LOE FS-500d, 243238P1LOEb, 14351020 FS-2d |  | 0d |  | finish on or before 2015-12-31 | 8/5 M-F w/JLAB Holidays ReBaseline |  |  | YOUNG G |  | 1 | 1 | 3 | YOUNG G |  |  |  |  |  | PR |  |  |  |  |  |  |  |  |  | 11-026 |  |  | 09-028 | 09-028 | M |  |  |  |  | 10-069 | 11-046 |  | 12-012 | 12-036 |  |  |  |  |  |  |  |  |  | 12-054 |  |  |  |  |
| 2-33M |  | Hall C Beam Commissioning Complete | milestone | 0d | 2016-02-08 | 2016-02-08 | 2823X000, 2812035, 2811050 |  | 38d | 0d | finish on or before 2016-03-31 | 8/5 M-F w/JLAB Holidays ReBaseline |  |  | YOUNG G |  | 1 | 1 | 3 | YOUNG G |  |  |  |  |  | PR |  |  |  |  |  |  |  |  |  | 11-026 |  |  | 09-028 | 09-028 | M |  |  |  |  |  |  |  | 12-012 | 12-036 |  |  |  |  |  |  |  |  |  | 12-054 | 2-33M | IPL | 13-006 |  |
| 2-37M |  | Hall B Beam Commissioning Complete | milestone | 0d | 2016-02-10 | 2016-02-10 | 2822X000, 2811035, 2812020 |  | 36d | 0d | finish on or before 2016-03-31 | 8/5 M-F w/JLAB Holidays ReBaseline |  |  | ELOUADRHIRI L |  | 1 | 1 | 3 | YOUNG G |  |  |  |  |  | PR |  |  |  |  |  |  |  |  |  | 11-026 |  |  | 09-028 | 09-028 | M |  |  |  |  |  |  |  |  |  |  |  |  |  |  | 12-024 | 13-002 |  |  |  | 2-37M | IPL |  | 13-010 |

Notes:
- 2-01M: Scope: added 05/04/07 in rev w JM and CR
- 2-04M: Scope: Design reports specifying the / reference designs of all new superconducting magnets are complete / Corrective Actions: Changed The Finish on or before date to 28Sept2007. per CHR 09 / Aug2007 (PMC)
- 2-05M: Scope: The first contract for fabrication of / a new Superconducting Magnet has been awarded
- 2-06M: Scope: The first contract for fabrication of / a new Superconducting Magnet has been awarded
- 2-07M: Scope: Installation of new experimental / equipment for Halls A, B, and C has started
- 2-08M: Scope: Installation of new experimental / equipment for Halls A, B, and C has finished
- 2-09M: Scope: Made level 2 from level 3 4/11/07 RKC renamed / from 3P-61M
- 2-36M: Scope: Installation of experimental equipment / into Hall B is complete
- 2-32M: Scope: Installation of experimental equipment / into Hall C is complete
- 2-33M: Scope: Complete electron beam commissioning / of Hall C detectors, electronics, and beamline devices / Explanation: IPL from 6 GeV 5333065, 5333070 and 5333075 / Added FY14 Funding Predeccessor with 57.6 weeks lag to bring start date out / to match 6 GeV impact
- 2-37M: Scope: Complete electron beam commissioning / of Hall B detectors, electronics, and beamline devices / Explanation: IPL from 6 GeV 5333065, 5333070 and 5333075 / Added FY14 Funding Predeccessor with 57.6 weeks lag to bring start date out / to match 6 GeV impact

| ID | WBS | Activity | Type | Duration | Start | Finish | Predecessors | Complete | Total float | Free float | Constraint | Calendar | PPEP Date | RESP - Responsibility | STRT%COMP for CM EVM | FNSH%COMP for CM EVM | Milestone Level | 12 GeV 3rd level Critical Path | HALL D Related Milestones | CIVIL CRITICAL MILESTONES | CAM RESPONSIBLE | CR 10-042 | CR 10-061 | CR 11-004 | CR 11-036 | 12 GeV 1st level Critical Path | CR 09-014 | CR 11-006 | CR 11-026 | CR 12-021 | Post Rebaseline | GROP Group | CR 09-028 | CR 09-028 Repair | CR 12-025 | CR 10-051 | CR 12-018 | CR 10-020 | CR 12-015 | Planned FinishUDF | Profile change | CR 08-002 | CR 07-032 | CR 09-031 | CR 09-031 Repair | CR 09-040 | CR 10-039 |
| --- | --- | --- | --- | --- | --- | --- | --- | --- | --- | --- | --- | --- | --- | --- | --- | --- | --- | --- | --- | --- | --- | --- | --- | --- | --- | --- | --- | --- | --- | --- | --- | --- | --- | --- | --- | --- | --- | --- | --- | --- | --- | --- | --- | --- | --- | --- | --- |
|  | 1.02D1 | **1.02D LEVEL 2 HALL D MILESTONES** |  |  | 2010-11-29 | 2014-12-11 |  |  |  |  |  |  |  |  |  |  |  |  |  |  |  |  |  |  |  |  |  |  |  |  |  |  |  |  |  |  |  |  |  |  |  |  |  |  |  |  |  |
| 2-10M |  | Start Hall-D Installation | milestone | 0d | 2010-11-29 | 2010-11-29 | 2-16M |  | 1d | 0d | start on or before 2010-11-30 |  | 2009-09-30 | RODE C | 1 | 1 | 2 | 3 | D | CVL | CLAUS R | 10-042 | 10-061 |  |  |  |  |  |  |  |  |  |  |  |  |  |  |  |  |  |  |  |  |  |  |  |  |
| 2-11M |  | Installation of Hall-D Solenoid Completed | milestone | 0d | 2013-02-20 | 2013-02-20 | 151250M |  | 91d | 155d | finish on or before 2013-06-28 |  | 2011-03-31 | RODE C | 1 | 1 | 2 |  | D |  | CLAUS R | 10-042 |  | 11-004 | 11-036 |  |  |  |  |  |  |  |  |  |  |  |  |  |  |  |  |  |  |  |  |  |  |
| 2-12M |  | Hall-D Equipment Installation Completed | milestone | 0d | 2014-09-30 | 2014-09-30 | 3A-53M, 282462045, 282462010, 1546182, 1543013E, 2543144, 251666, 15221012E, 1562180, 2562180, 2562790 FS-500d, 1562670a, 1562260, 1562335, 2562780, 2562835, 2562355, 2562495, 2562445, 2531375, 2532060, 2532195, 1553075, 2553011, 2553210, 25211217a, 2532170aa, 2562355b, 282443025a5a, 282446000a, 282462050, 2546655, 2541000, 2543185, 25221010, 2562170, 2562181, 1562650, 1562330, 1562670, 2562281, 2562420, 2562630, 2531370, 2531227aa, 2532115, 25211260a, 2546620b, 2553011a, 13326000, 282443025a, 282446000, 282432015, 2546640, 15211210, 25211255LOE5, 25221005, 1562630, 1562405, 2562855, 2562510, 2562460, 2562006LOE, 2531089, 2532000, 2532014E FS-500d, 2553029, 2541015a, 2543144a, 2543160a, 2562181a, 2562181b, 2562355a, 2562445a, 13326015, 2546465, 2546565, 2546610, 2546620, 2541015, 25211250, 25221000, 25221010LOE, 2562235, 1562625, 1562635, 1562595a, 1562600, 1562595, 2562860, 2562335, 2562625, 2562635, 2531227aa5, 2531360, 2531380, 2531400, 2531178 FS-100d, 2532220, 2532240, 2553157, 2546650a, 282443025a5, 25213030, 282462030, 2541154, 2541155, 2543160, 2562175, 2562206, 1562645, 1562270, 2562482, 2562216, 2562785 FS-500d, 2562595a, 2532170a, 2532255, 2532110, 2546610a, 2546620a, 2562335a, 2562335b, 2562482a, 13326010, 282432010, 282432005, 282462015, 282462040, 2546630, 2542085, 2542090, 2543165, 25211217, 2562165, 1562685, 1562400, 2562895, 2562900, 2562685, 2562014E, 2531385, 2531395, 2531088, 2532245, 2532175a, 2532075, 2532090, 2543165a, 2971000, 282462025, 2546615, 2546625, 2546645, 1541013E, 2542037, 25212010, 25212185 FS-103d, 1562260a, 2562637, 2532225, 2532085, 2532180, 2553075, 295222000, 282432025, 282462020, 282462035, 2546650, 2542080, 2543143, 25211255LOE, 25211260, 1562655, 1562665, 2562885, 2562615LOE FS-245d, 2562091M, 2531365 FS-500d, 2532235, 25212185a FS-103d, 2562895a |  | 0d |  | finish on or before 2014-09-30 | 8/5 M-F w/JLAB Holidays ReBaseline | 2012-06-29 | RODE C | 1 | 1 | 2 |  | D | CVL | CLAUS R |  |  |  |  | 1 | 09-014 | 11-006 | 11-026 | 12-021 | PR |  |  |  |  |  |  |  |  |  |  |  |  |  |  |  |  |
| 2-13M |  | Hall-D Beam Commissioning Completed | milestone | 0d | 2014-12-11 | 2014-12-11 | 2824X000, 28241000a, 2812050, 2811065, 28241000 |  | 8d | 70d | finish on or before 2014-12-31 | 8/5 M-F w/JLAB Holidays ReBaseline |  | RODE C | 1 | 1 | 2 |  | D |  | CLAUS R |  |  |  |  | 1 |  | 11-006 | 11-026 | 12-021 | PR | ACCL | 09-028 | 09-028 | 12-025 |  |  |  |  |  |  |  |  |  |  |  |  |
|  | 1.02C | **1.02C LEVEL 2 CIVIL MILESTONES** |  |  | 2008-09-04 | 2015-10-02 |  |  |  |  |  |  |  |  |  |  |  |  |  |  |  |  |  |  |  |  |  |  |  |  |  |  |  |  |  |  |  |  |  |  |  |  |  |  |  |  |  |
| 2-14M |  | Design of Conventional Facilties Completed | milestone | 0d | 2008-09-04 | 2008-09-04 | 3C-02M FS+40d, 1241075M, 1241155M, 1241195M, 1241115M, 3C-01M |  | 18d | 1257d | finish on or before 2008-09-30 |  | 2008-09-30 | RODE C | 1 | 1 | 2 |  |  |  | CLAUS R |  |  |  |  |  |  |  |  |  |  |  |  |  |  |  |  |  |  |  |  |  |  |  |  |  |  |
| 2-15M |  | Ready for Equipment-CHL Addition (RFE) (doesn't Include Elect & Cooling Water Util Distrbtn) | milestone | 0d | 2010-03-12 | 2010-03-12 | 1621010 FS+60d |  | 141d | 0d | finish on or before 2010-09-30 |  | 2009-03-31 | RODE C | 1 | 1 | 2 |  | D |  | CLAUS R |  |  |  |  |  |  |  |  |  |  |  |  |  |  |  |  |  |  |  |  |  |  |  |  |  |  |
| 2-16M |  | Ready for Equipment - H-D (RFE) | milestone | 0d | 2010-11-24 | 2010-11-24 | 16331032, 16331030 |  | 1d | 0d | finish on or before 2010-11-30 |  | 2009-06-30 | RODE C | 1 | 1 | 2 | 3 | D | CVL | CLAUS R | 10-042 | 10-061 |  |  |  |  |  |  |  |  |  |  |  |  | 10-051 |  |  |  |  |  |  |  |  |  |  |  |
| 2-17M |  | Accelerator Tunnel Extension Completed (existing tunnel) | milestone | 0d | 2011-11-01 | 2011-11-01 | 16333030 |  | 183d | 225d | finish on or before 2012-07-31 |  | 2011-06-30 | RODE C | 1 | 1 | 2 |  |  |  | CLAUS R |  |  |  |  |  |  |  | 11-026 |  |  |  |  |  |  |  | 12-018F |  |  |  |  |  |  |  |  |  |  |
| 2-38M |  | Conventional Facilt's Comptd | milestone | 0d | 2015-10-02 | 2015-10-02 | 16222035M, 16333035, 1621020, 16332035, 16113030M, 26115045M, 26112030M, 1621015b, 16331035M, 26114030M, 16111030M, 1621030, 16122030M |  | 56d | 0d | finish on or before 2015-12-31 | 8/5 M-F w/JLAB Holidays ReBaseline |  | YASKY R | 1 | 1 | 3 |  |  |  | REBECCA Y |  |  |  |  |  |  |  |  |  | PR |  |  |  |  |  |  | 10-020 | 12-015 |  |  |  |  |  |  |  |  |
|  | 1.02PM | **1.02PM LEVEL 2 PROJECT MANAGEMENT MILESTONES-1** |  |  | 2005-09-29 | 2008-06-30 |  |  |  |  |  |  |  |  |  |  |  |  |  |  |  |  |  |  |  |  |  |  |  |  |  |  |  |  |  |  |  |  |  |  |  |  |  |  |  |  |  |
| 2-18M |  | Preliminary Hazard Assessment Submitted to DOE | milestone | 0d | 2005-09-29 A | 2005-09-29 A |  | 100% |  |  |  |  | 2009-06-30 | RODE C | 1 | 1 | 2 |  |  |  | CLAUS R |  |  |  |  |  |  |  |  |  |  |  |  |  |  |  |  |  |  | 2005-09-29 |  |  |  |  |  |  |  |
| 2-19M |  | EA Completed | milestone | 0d | 2006-10-02 | 2006-10-02 | 1-2M |  | 1d | 184d | finish on or before 2006-10-02 |  | 2006-09-29 | RODE C | 1 | 1 | 2 |  |  |  | CLAUS R |  |  |  |  |  |  |  |  |  |  |  |  |  |  |  |  |  |  | 2006-10-02 |  |  |  |  |  |  |  |
| 2-20M |  | Completion of Land Transfer | milestone | 0d | 2006-10-02 | 2006-10-02 | 1-2M |  | 184d |  | finish on or before 2007-06-29 |  | 2006-09-29 | RODE C | 1 | 1 | 2 |  |  |  | CLAUS R |  |  |  |  |  |  |  |  |  |  |  |  |  |  |  |  |  |  | 2006-10-02 |  |  |  |  |  |  |  |
| 2-21M |  | PEP Issued | milestone | 0d | 2006-10-02 | 2006-10-02 | 1-2M |  | 184d |  | finish on or before 2007-09-28 |  |  | RODE C | 1 | 1 | 2 |  |  |  | CLAUS R |  |  |  |  |  |  |  |  |  |  |  |  |  |  |  |  |  |  | 2007-09-28 |  |  |  |  |  |  |  |
| 2-22M |  | OECM EVMS Contractor Certification REVIEW CompleteD | milestone | 0d | 2008-01-31 | 2008-01-31 | 1252015 |  | 0d |  | mandatory finish 2008-01-31 |  |  | RODE C | 1 | 1 | 2 |  |  |  | CLAUS R |  |  |  |  |  |  |  |  |  |  |  |  |  |  |  |  |  |  |  | C | 08-002 |  |  |  |  |  |
| 2-23M |  | Accelerator Safety Envelope (ASE) Completed | milestone | 0d | 2008-06-30 | 2008-06-30 | 1251908LOEB FS-65d, 9-080M FS+125d |  | 1d | 23d | finish on or before 2008-06-30 |  | 2007-06-29 | RODE C | 1 | 1 | 2 |  |  |  | CLAUS R |  |  |  |  |  |  |  |  |  |  |  |  |  |  |  |  |  |  |  | C |  | 07-032 |  |  |  |  |
| 2-24M |  | Safety Assessmnt Document (SAD) Completed | milestone | 0d | 2008-06-30 | 2008-06-30 | 9-080M FS+125d, 1251908LOEB FS-65d |  | 1d | 23d | finish on or before 2008-06-30 |  | 2007-06-29 | RODE C | 1 | 1 | 2 |  |  |  | CLAUS R |  |  |  |  |  |  |  |  |  |  |  |  |  |  |  |  |  |  |  | C |  | 07-032 |  |  |  |  |
|  | 1.02R | **1.02R LEVEL 2 REVIEW MILESTONES** |  |  |  |  |  |  |  |  |  |  |  |  |  |  |  |  |  |  |  |  |  |  |  |  |  |  |  |  |  |  |  |  |  |  |  |  |  |  |  |  |  |  |  |  |  |
|  | 1.02S | **1.02S LEVEL 2 STIMULUS MILESTONES** |  |  | 2009-01-08 | 2010-10-01 |  |  |  |  |  |  |  |  |  |  |  |  |  |  |  |  |  |  |  |  |  |  |  |  |  |  |  |  |  |  |  |  |  |  |  |  |  |  |  |  |  |
| 2-S02M |  | Award Central Helium Liquifer 4.5K Coldbox Subcontract | milestone | 0d | 2009-01-08 | 2009-01-08 | 1331.02000 FS-185d |  | 120d | 1480d | start on or before 2009-06-30 |  | 2010-12-31 | RODE C | 1 | 1 | 2 |  |  |  | CLAUS R |  |  |  |  |  |  |  |  |  |  |  |  |  |  |  |  |  |  |  |  |  |  | 09-031 | 09-031 |  |  |
| 2-S01M |  | Award 4 Meter Dipole Magnet Subcontract | milestone | 0d | 2009-01-13 | 2009-01-13 | 13451060M |  | 117d | 1477d | start on or before 2009-06-30 |  | 2010-12-31 | RODE C | 1 | 1 | 2 |  |  |  | CLAUS R |  |  |  |  |  |  |  |  |  |  |  |  |  |  |  |  |  |  |  |  |  |  | 09-031 | 09-031 |  |  |
| 2-S03M |  | Award Quad Magnets Subcontracts | milestone | 0d | 2009-08-03 | 2009-08-03 | 13452030M |  | -23d | 1337d | start on or before 2009-06-30 |  | 2010-12-31 | RODE C | 1 | 1 | 2 |  |  |  | CLAUS R |  |  |  |  |  |  |  |  |  |  |  |  |  |  |  |  |  |  |  |  |  |  | 09-031 | 09-031 | 09-040 |  |
| 2-S04M |  | Award Cryomodules Spaceframes Subcontract | milestone | 0d | 2009-08-04 | 2009-08-04 | 131121010 |  | 19d | 1336d | start on or before 2009-08-31 |  | 2010-12-31 | RODE C | 1 | 1 | 2 |  |  |  | CLAUS R |  |  |  |  |  |  |  |  |  |  |  |  |  |  |  |  |  |  |  |  |  |  | 09-031 | 09-031 |  |  |
| 2-S10M |  | Award North & South Access Building Subcontract | milestone | 0d | 2009-10-01 | 2009-10-01 | 16111000M |  | 162d | 1295d | start on or before 2010-05-31 |  | 2010-12-31 | RODE C | 1 | 1 | 2 |  |  |  | CLAUS R |  |  |  |  |  |  |  |  |  |  |  |  |  |  |  |  |  |  |  |  |  |  | 09-031 | 09-031 |  |  |
| 2-S07M |  | Award High-Voltage Cathode Power Supply Subcontract | milestone | 0d | 2009-10-08 | 2009-10-08 | 1321121010 |  | 72d | 1290d | start on or before 2010-01-29 |  | 2010-12-31 | RODE C | 1 | 1 | 2 |  |  |  | CLAUS R |  |  |  |  |  |  |  |  |  |  |  |  |  |  |  |  |  |  |  |  |  |  | 09-031 | 09-031 |  |  |
| 2-S05M |  | Award Cryomodules Vacuum Vessels Subcontract | milestone | 0d | 2009-11-03 | 2009-11-03 | 131136010 |  | 17d | 1272d | start on or before 2009-11-30 |  | 2010-12-31 | RODE C | 1 | 1 | 2 |  |  |  | CLAUS R |  |  |  |  |  |  |  |  |  |  |  |  |  |  |  |  |  |  |  |  |  |  | 09-031 | 09-031 |  |  |
| 2-S08M |  | Award Central Helium Liquifer Compressors Subcontract | milestone | 0d | 2010-01-12 | 2010-01-12 | 1331.01010 FS-77d, 1331.01000 FS-240d |  | 31d | 1230d | start on or before 2010-02-26 |  | 2010-12-31 | RODE C | 1 | 1 | 2 |  |  |  | CLAUS R |  |  |  |  |  |  |  |  |  |  |  |  |  |  |  |  |  |  |  |  |  |  | 09-031 | 09-031 |  | 10-039 |
| 2-S06M |  | Award End Can Subcontract | milestone | 0d | 2010-02-03 | 2010-02-03 | 131135010 |  | -25d | 1215d | start on or before 2009-12-21 |  | 2010-12-31 | RODE C | 1 | 1 | 2 |  |  |  | CLAUS R |  |  |  |  |  |  |  |  |  |  |  |  |  |  |  |  |  |  |  |  |  |  | 09-031 | 09-031 |  |  |
| 2-S11M |  | Award Final Stimulus Subcontract | milestone | 0d | 2010-09-30 | 2010-09-30 | 1-6M |  | 0d |  | mandatory finish 2010-09-30 |  | 2010-12-31 | RODE C | 1 | 1 | 2 |  |  |  | CLAUS R |  |  |  |  |  |  |  |  |  |  |  |  |  |  |  |  |  |  |  |  |  |  | 09-031 | 09-031 |  |  |
| 2-S09M |  | Award Box Power Supply Subcontract | milestone | 0d | 2010-10-01 | 2010-10-01 | 13221004M |  | -129d | 1047d | start on or before 2010-03-31 |  | 2010-12-31 | RODE C | 1 | 1 | 2 |  |  |  | CLAUS R |  |  |  |  |  |  |  |  |  |  |  |  |  |  |  |  |  |  |  |  |  |  | 09-031 | 09-031 |  |  |

Notes:
- 2-10M: Scope: Installation of new experimental / equipment into Hall D or the tagging area has begun
- 2-11M: Scope: Installation of the Hall D solenoid / magnet, including its modified flux return yoke, has been / completed
- 2-12M: Scope: Installation of all experimental / equipment into Hall D and the tagger area is complete
- 2-13M: Scope: Made level 2 from level 3 4/11/07 RKC Renamed from 3P-63M
- 2-14M: Scope: Complete / all Civil design work - both in-house and A-E designs packages. Milestones 3-09M and 3-10M are / predecessors.
- 2-15M: Scope: Civil / construction completion of the CHL building addition and ready for equipment / installation to start. It does not / include the electrical and cooling water utility / distribution.
- 2-16M: Scope: Civil / construction completion of Experimental Hall D and ready for equipment / installation to start.
- 2-17M: Scope: Connection / of the new tunnel extension to the existing Accelerator tunnel is / complete.

| ID | WBS | Activity | Type | Duration | Start | Finish | Predecessors | Total float | Free float | Constraint | Calendar | PPEP Date | RESP - Responsibility | STRT%COMP for CM EVM | FNSH%COMP for CM EVM | Milestone Level | CAM RESPONSIBLE | CR 09-023 | GROP Group | MILE - Milestone | CR 09-053 | CR 12-028 | CR 10-028 | CR 10-031 | CR 10-064 | CR 10-066 | CR 12-018 | CR 13-009 | CR 10-065 | CR 12-035 | CR 11-042 | Inter Project Link (IPL) | CR 10-059 | CR 11-044 | CR 12-037 | CR 11-051 | CR 10-040 | CR 11-055 | CR 12-029 | CR 12-050 | CR 11-015 | CR 11-043 | CR 12-025 | Post Rebaseline | CR 11-026 | CR 10-070 | CR 12-026 |
| --- | --- | --- | --- | --- | --- | --- | --- | --- | --- | --- | --- | --- | --- | --- | --- | --- | --- | --- | --- | --- | --- | --- | --- | --- | --- | --- | --- | --- | --- | --- | --- | --- | --- | --- | --- | --- | --- | --- | --- | --- | --- | --- | --- | --- | --- | --- | --- |
|  | 1.03A | **1.03A LEVEL 3 ACCELERATOR MILESTONES** |  |  | 2009-04-21 | 2014-02-07 |  |  |  |  |  |  |  |  |  |  |  |  |  |  |  |  |  |  |  |  |  |  |  |  |  |  |  |  |  |  |  |  |  |  |  |  |  |  |  |  |  |
| 32-01M |  | Award Initial Major Acc contract | milestone | 0d | 2009-04-21 | 2009-04-21 | 132111025M | -37d | 0d | start on or before 2009-02-27 |  | 2010-12-31 | HARWOOD L | 1 | 1 | 3 | LEIGH H | 09-023 |  |  |  |  |  |  |  |  |  |  |  |  |  |  |  |  |  |  |  |  |  |  |  |  |  |  |  |  |  |
| 3A-01M |  | Start Linac Installtn | milestone | 0d | 2009-10-01 | 2009-10-01 | 9-100M | 431d | 307d | start on or before 2011-06-30 |  |  | HARWOOD L | 1 | 1 | 3 | LEIGH H |  | ACCL | 4 |  |  |  |  |  |  |  |  |  |  |  |  |  |  |  |  |  |  |  |  |  |  |  |  |  |  |  |
| 32-02M |  | Vendor Dsgn Review of 4K Coldbox | milestone | 0d | 2010-01-29 | 2010-01-29 | 1331.02025, 1331.02000 FS-65d | 0d | 170d | finish on or before 2010-01-31 |  | 2008-06-30 | HARWOOD L | 1 | 1 | 3 | LEIGH H |  |  |  | 09-053 |  |  |  |  |  |  |  |  |  |  |  |  |  |  |  |  |  |  |  |  |  |  |  |  |  |  |
| 32-03M |  | Start Accel Component Assy | milestone | 0d | 2010-03-18 | 2010-03-18 | 9-100M FS+110d | 73d | 0d | start on or before 2010-06-30 |  | 2008-12-31 | HARWOOD L | 1 | 1 | 3 | LEIGH H |  |  |  |  | 12-028F |  |  |  |  |  |  |  |  |  |  |  |  |  |  |  |  |  |  |  |  |  |  |  |  |  |
| 3A-02M |  | Start LLRF Installtn | milestone | 0d | 2010-10-01 | 2010-10-01 | 9-110M | 161d | 193d | start on or before 2011-05-31 |  |  | HARWOOD L | 1 | 1 | 3 | LEIGH H |  | ACCL | 4 |  |  |  |  |  |  |  |  |  |  |  |  |  |  |  |  |  |  |  |  |  |  |  |  |  |  |  |
| 3A-03M |  | Start Pwr (rf) Installtn | milestone | 0d | 2011-01-04 | 2011-01-04 | 4A-03M | 267d | 1d | start on or before 2012-01-31 |  |  | HARWOOD L | 1 | 1 | 3 | LEIGH H |  | ACCL | 4 |  | 12-028F | 10-028 | 10-031 | 10-064 | 10-066 | 12-018F | 13-009F |  |  |  |  |  |  |  |  |  |  |  |  |  |  |  |  |  |  |  |
| 3A-29M |  | West Arc Removl Comptd | milestone | 0d | 2011-05-13 | 2011-05-13 | 4A-01M | 60d | 0d |  |  |  | HARWOOD L | 1 | 1 | 3 | LEIGH H |  | ACCL | 4 |  |  |  |  |  |  |  |  | 10-065 | 12-035 |  |  |  |  |  |  |  |  |  |  |  |  |  |  |  |  |  |
| 3A-34M |  | Start West Arc Installtn | milestone | 0d | 2011-05-13 | 2011-05-13 | 3A-29M | 60d | 14d |  |  |  | HARWOOD L | 1 | 1 | 3 | LEIGH H |  | ACCL | 4 |  |  |  |  |  |  |  |  | 10-065 | 12-035 |  |  |  |  |  |  |  |  |  |  |  |  |  |  |  |  |  |
| 3A-21M |  | Start Pwr (Mag) Installtn | milestone | 0d | 2011-06-13 | 2011-06-13 | 13224020, 9-110M FS+170d, 13224010, 13224005, 13224030, 13224025, 13224015 | 324d | 228d | start on or before 2012-09-28 |  |  | HARWOOD L | 1 | 1 | 3 | LEIGH H |  | ACCL | 4 |  |  | 10-028 |  |  |  |  |  |  |  | 11-042 |  |  |  |  |  |  |  |  |  |  |  |  |  |  |  |  |
| 3A-20M |  | Start Cryomodule Installtn | milestone | 0d | 2011-08-12 | 2011-08-12 | 131401000, 3A-01M, 13643172M | 83d | 23d | start on or before 2012-09-28 |  |  | HARWOOD L | 1 | 1 | 3 | LEIGH H |  | ACCL | 4 |  |  |  | 10-031 | 10-064 | 10-066 |  |  | 10-065 |  |  |  |  |  |  |  |  |  |  |  |  |  |  |  |  |  |  |
| 3A-04M |  | Start 2nd Cryogenics Plant Commssng | milestone | 0d | 2011-10-03 | 2011-10-03 | 3C-07M, 1331.07000a, 1331.01000, 1331.02001, 1331.09000 FS+60d, 1331.1000a, 1331.1000b, 1331.02000, 1331.12000, 1331.08000, 1331.02070, 1331.01110, 1331.02012, 12131.11010, 16222035M, 1621015b FS+130d, 9-120M, 1621020 FS+130d, 1331.06000, 1331.03000, 1331.07000b, 1331.01005A, 1331.02015 | 40d | 0d | start on or before 2011-11-30 |  |  | HARWOOD L | 1 | 1 | 3 | LEIGH H |  | CVL | 4 |  |  |  |  |  |  |  |  |  |  |  | IPL |  |  |  |  |  |  |  |  |  |  |  |  |  |  |  |
| 3A-07M |  | Start PSS Installtn | milestone | 0d | 2012-01-23 | 2012-01-23 | 16331032, 3A-09M, 16332030, 16331030, 13643040b, 13643040c | 6d | 0d | start on or before 2012-01-31 |  |  | HARWOOD L | 1 | 1 | 3 | LEIGH H |  | ACCL | 4 |  |  |  |  |  |  |  |  |  |  |  |  | 10-059 | 11-044 |  |  |  |  |  |  |  |  |  |  |  |  |  |
| 3A-09M |  | Start I&C/Sfty Installtn | milestone | 0d | 2012-01-23 | 2012-01-23 | 13643090, 13643085 | 6d | 0d | start on or before 2012-01-31 |  |  | HARWOOD L | 1 | 1 | 3 | LEIGH H |  | ACCL | 4 |  |  |  |  |  |  |  |  |  |  |  |  | 10-059 | 11-044 |  |  |  |  |  |  |  |  |  |  |  |  |  |
| 3A-08M |  | Start MPS Installtn | milestone | 0d | 2012-03-19 | 2012-03-19 | 13641014, 3A-09M, 16332030, 16331032, 16331030 | 30d | 0d | start on or before 2012-04-30 |  |  | HARWOOD L | 1 | 1 | 3 | LEIGH H |  | ACCL | 4 |  |  |  |  |  |  |  |  |  |  |  |  |  |  | 12-037 |  |  |  |  |  |  |  |  |  |  |  |  |
| 3A-59M |  | Test Lab Ready for Renovation | milestone | 0d | 2012-05-01 | 2012-05-01 | 1312410010 | 0d |  | mandatory finish 2012-05-01 |  |  | HARWOOD L | 1 | 1 | 3 | LEIGH H |  |  |  |  |  |  |  |  |  | 12-018 |  |  |  |  |  |  |  |  | 11-051 |  |  |  |  |  |  |  |  |  |  |  |
| 3A-12M |  | Start H-D BL Installtn | milestone | 0d | 2012-05-14 | 2012-05-14 | 2-02M | 402d | 175d |  |  |  | HARWOOD L | 1 | 1 | 3 | LEIGH H |  | ACCL | 4 |  |  |  |  |  |  |  |  |  | 12-035 |  |  |  |  |  |  |  |  |  |  |  |  |  |  |  |  |  |
| 3A-13M |  | Start West Arc Removl | milestone | 0d | 2012-05-14 | 2012-05-14 | 2-02M | 200d | 0d |  |  |  | HARWOOD L | 1 | 1 | 3 | LEIGH H |  | ACCL | 4 |  |  |  |  |  |  |  |  | 10-065 | 12-035 |  |  |  |  |  |  |  |  |  |  |  |  |  |  |  |  |  |
| 3A-14M |  | Start East Arc Removl | milestone | 0d | 2012-05-14 | 2012-05-14 | 3A-13M, 2-02M | 200d | 56d |  |  |  | HARWOOD L | 1 | 1 | 3 | LEIGH H |  | ACCL | 4 |  |  |  |  |  |  |  |  | 10-065 | 12-035 |  |  |  |  |  |  |  |  |  |  |  |  |  |  |  |  |  |
| 3A-16M |  | Start H-A BL Removl | milestone | 0d | 2012-05-14 | 2012-05-14 | 2-02M | 313d | 112d |  |  |  | HARWOOD L | 1 | 1 | 3 | LEIGH H |  | ACCL | 4 |  |  |  |  |  |  |  |  | 10-065 | 12-035 |  |  |  |  |  |  |  |  |  |  |  |  |  |  |  |  |  |
| 3A-17M |  | Start H-B BL Removl | milestone | 0d | 2012-05-14 | 2012-05-14 | 2-02M | 315d | 108d |  |  |  | HARWOOD L | 1 | 1 | 3 | LEIGH H |  | ACCL | 4 |  |  |  |  |  |  |  |  | 10-065 | 12-035 |  |  |  |  |  |  |  |  |  |  |  |  |  |  |  |  |  |
| 3A-18M |  | Start H-C BL Removl | milestone | 0d | 2012-05-14 | 2012-05-14 | 2-02M | 320d | 113d |  |  |  | HARWOOD L | 1 | 1 | 3 | LEIGH H |  | ACCL | 4 |  |  |  |  |  |  |  |  | 10-065 | 12-035 |  |  |  |  |  |  |  |  |  |  |  |  |  |  |  |  |  |
| 3A-19M |  | Start S/R Removl | milestone | 0d | 2012-05-14 | 2012-05-14 | 2-02M | 307d | 23d |  |  |  | HARWOOD L | 1 | 1 | 3 | LEIGH H |  | ACCL | 4 |  |  |  |  |  |  |  |  | 10-065 | 12-035 |  | IPL |  |  |  |  |  |  |  |  |  |  |  |  |  |  |  |
| 3A-22M |  | Start Trim Supply Installtn | milestone | 0d | 2012-05-14 | 2012-05-14 | 2-02M | 216d | 0d |  |  |  | HARWOOD L | 1 | 1 | 3 | LEIGH H |  | ACCL | 4 |  | 12-028 | 10-028 |  |  |  |  |  |  |  |  |  |  |  |  |  |  |  |  |  |  |  |  |  |  |  |  |
| 3A-30M |  | East Arc Removl Comptd | milestone | 0d | 2012-08-13 | 2012-08-13 | 13427020 | 193d | 0d |  |  |  | HARWOOD L | 1 | 1 | 3 | LEIGH H |  | ACCL | 4 |  |  |  |  |  |  |  |  | 10-065 | 12-035 |  |  |  |  |  |  |  |  |  |  |  |  |  |  |  |  |  |
| 3A-36M |  | Start East Arc Installtn | milestone | 0d | 2012-08-14 | 2012-08-14 | 2-02M, 3A-30M | 193d | 0d |  |  |  | HARWOOD L | 1 | 1 | 3 | LEIGH H |  | ACCL | 4 |  |  |  |  |  |  |  |  | 10-065 | 12-035 |  |  |  |  |  |  |  |  |  |  |  |  |  |  |  |  |  |
| 3A-28M |  | H-A BL Removl Comptd | milestone | 0d | 2012-10-19 | 2012-10-19 | 13427035 | 201d | 0d |  | 8/5 M-F w/JLAB Holidays ReBaseline |  | HARWOOD L | 1 | 1 | 3 | LEIGH H |  |  |  |  |  |  |  |  |  |  |  | 10-065 | 12-035 |  |  |  |  |  |  |  |  |  |  |  |  |  |  |  |  |  |
| 3A-37M |  | Start H-A BL Installtn | milestone | 0d | 2012-10-22 | 2012-10-22 | 3A-28M, 2-02M, 3A-16M | 201d | 15d |  |  |  | HARWOOD L | 1 | 1 | 3 | LEIGH H |  | ACCL | 4 |  |  |  |  |  |  |  |  | 10-065 | 12-035 |  |  |  |  |  |  |  |  |  |  |  |  |  |  |  |  |  |
| 3A-31M |  | H-B BL Removl Comptd | milestone | 0d | 2012-11-02 | 2012-11-02 | 13427042 | 290d | 0d |  | 8/5 M-F w/JLAB Holidays ReBaseline |  | HARWOOD L | 1 | 1 | 3 | LEIGH H |  | ACCL | 4 |  |  |  |  |  |  |  |  | 10-065 | 12-035 |  |  |  |  |  |  |  |  |  |  |  |  |  |  |  |  |  |
| 3A-38M |  | Start H-B BL Installtn | milestone | 0d | 2012-11-05 | 2012-11-05 | 3A-31M, 2-02M, 3A-17M | 292d | 0d |  |  |  | HARWOOD L | 1 | 1 | 3 | LEIGH H |  | ACCL | 4 |  |  |  |  |  |  |  |  | 10-065 | 12-035 |  |  |  |  |  |  |  |  |  |  |  |  |  |  |  |  |  |
| 3A-32M |  | H-C BL Removl Comptd | milestone | 0d | 2012-11-09 | 2012-11-09 | 13427050 | 346d | 0d |  | 8/5 M-F w/JLAB Holidays ReBaseline |  | HARWOOD L | 1 | 1 | 3 | LEIGH H |  | ACCL | 4 |  |  |  |  |  |  |  |  | 10-065 | 12-035 |  |  |  |  |  |  |  |  |  |  |  |  |  |  |  |  |  |
| 3A-33M |  | Start H-C BL Installtn | milestone | 0d | 2012-11-12 | 2012-11-12 | 3A-32M, 2-02M | 347d | 19d |  |  |  | HARWOOD L | 1 | 1 | 3 | LEIGH H |  | ACCL | 4 |  |  |  |  |  |  |  |  | 10-065 | 12-035 |  |  |  |  |  |  |  |  |  |  |  |  |  |  |  |  |  |
| 3A-52M |  | East arc Installtn Comptd | milestone | 0d | 2013-02-14 | 2013-02-14 | 13427032 | 168d |  |  |  |  | HARWOOD L | 1 | 1 | 3 | LEIGH H |  | ACCL | 4 |  | 12-028 |  |  |  |  |  |  | 10-065 | 12-035 |  | IPL |  |  |  |  |  |  |  |  |  |  |  |  |  |  |  |
| 3A-10M |  | LLRF Installtn Comptd | milestone | 0d | 2013-02-15 | 2013-02-15 | 132121070M | 167d | 32d |  |  |  | HARWOOD L | 1 | 1 | 3 | LEIGH H |  | ACCL | 4 |  | 12-028 | 10-028 |  |  |  |  |  |  |  |  |  |  |  |  |  |  |  |  |  |  |  |  |  |  |  |  |
| 3A-23M |  | Start Box Supply Installtn | milestone | 0d | 2013-03-12 | 2013-03-12 | 13221024a FS-320d, 13221030, 16111025, 23221024ba FS-320d, 13221020a FS-207d | 126d | 110d |  |  |  | HARWOOD L | 1 | 1 | 3 | LEIGH H |  | ACCL | 4 |  |  | 10-028 |  |  |  |  |  |  |  |  |  |  |  |  |  | 10-040 | 11-055 | 12-029 | 12-050 |  |  |  |  |  |  |  |
| 3A-56M |  | West arc Installtn Comptd | milestone | 0d | 2013-03-12 | 2013-03-12 | 13427030 | 151d |  |  |  |  | HARWOOD L | 1 | 1 | 3 | LEIGH H |  | ACCL | 4 |  |  |  |  |  |  |  |  | 10-065 | 12-035 |  | IPL |  |  |  |  |  |  |  |  |  |  |  |  |  |  |  |
| 3A-40M |  | HPA Installtn Comptd | milestone | 0d | 2013-04-03 | 2013-04-03 | 132111057M, 132112090M, 132111115M | 135d | 0d |  |  |  | HARWOOD L | 1 | 1 | 3 | LEIGH H | 09-023 | ACCL | 4 |  | 12-028 | 10-028 |  |  |  |  |  |  |  |  |  |  |  |  |  |  |  |  |  | 11-015 | 11-043 |  |  |  |  |  |
| 3A-41M |  | Pwr (rf) Installtn Comptd | milestone | 0d | 2013-04-03 | 2013-04-03 | 3A-40M, 3A-10M, 132113090M | 135d | 134d |  |  |  | HARWOOD L | 1 | 1 | 3 | LEIGH H |  | ACCL | 4 |  | 12-028 |  |  |  |  |  |  |  |  |  |  |  |  |  |  |  |  |  |  |  |  |  |  |  |  |  |
| 3A-58M |  | End of Long Accel Constr Down | milestone | 0d | 2013-09-13 | 2013-09-13 | 13417170, 23417065 FS-15d, 13411150LOE, 23411145 FS-25d, 23427016LOE FS-45d, 13427021a, 13427024a, 132113135, 1352020, 23643355 FS-40d, 13643360, 23613913LOE FS-100d, 13422123, 23223125a FS-100d, 23612913LOE FS-100d, 23463050a FS-20d, 23447010 FS-5d, 13417030, 23417165 FS-15d, 13458045, 23611026b FS-15d, 23427016LOEa FS-45d, 23417150 FS-45d, 13416049, 23463050 FS-20d, 23223125 FS-100d, 13643355, 13436040, 13417035, 13417150, 13427050, 13427030, 2363913LOE FS-100d, 1367050, 13611026b, 13417040a, 13417020, 13427016LOE, 13422123b, 13422060, 13223125, 232111914LOE FS-500d, 2365913LOE FS-100d, 13447010, 23417170 FS-15d, 13427022a, 13427023a, 23223125b FS-100d, 23411145a FS-25d | 0d |  | mandatory finish 2013-09-13 |  |  | HARWOOD L | 1 | 1 | 3 | LEIGH H |  |  |  |  |  |  |  |  |  |  |  |  |  |  |  |  |  |  |  |  |  |  |  |  |  | 12-025 | PR |  |  |  |
| 3A-43M |  | H-A BL Installtn Comptd | milestone | 0d | 2013-10-11 | 2013-10-11 | 13427040, 23427040, 13221115, 23427040a | 48d | 0d |  |  |  | HARWOOD L | 1 | 1 | 3 | LEIGH H |  | ACCL | 4 |  |  |  |  |  |  | 12-018F |  | 10-065 | 12-035 |  |  |  |  |  |  |  |  | 12-029F |  |  |  | 12-025 | PR |  |  |  |
| 3A-47M |  | Cryomodule Installtn Comptd | milestone | 0d | 2013-10-11 | 2013-10-11 | 281315025a, 281315015, 181315025, 281315025 | 21d | 0d |  | 8/5 M-F w/JLAB Holidays ReBaseline |  | HARWOOD L | 1 | 1 | 3 | LEIGH H |  | ACCL | 4 |  | 12-028 |  |  | 10-064 | 10-066 | 12-018 |  |  |  |  |  |  |  |  |  |  |  |  |  |  |  |  | PR |  |  |  |
| 3A-54M |  | S/R Installtn Comptd | milestone | 0d | 2013-10-29 | 2013-10-29 | 13417040a, 23417145, 23417145a | 14d | 0d |  |  |  | HARWOOD L | 1 | 1 | 3 | LEIGH H |  | ACCL | 4 |  |  |  |  |  |  |  |  | 10-065 | 12-035 |  | IPL |  |  |  |  |  |  |  |  |  |  |  | PR |  |  |  |
| 3A-44M |  | H-B BL Installtn Comptd | milestone | 0d | 2013-11-11 | 2013-11-11 | 23427047, 13221115, 23427047a, 13427047 | 126d | 53d |  | 8/5 M-F w/JLAB Holidays ReBaseline |  | HARWOOD L | 1 | 1 | 3 | LEIGH H |  | ACCL | 4 |  |  |  |  |  |  | 12-018F |  | 10-065 | 12-035 |  |  |  |  |  |  |  |  | 12-029F |  |  |  | 12-025 | PR |  |  |  |
| 32-05M |  | Start Accel Beam Commssng | milestone | 0d | 2013-11-14 | 2013-11-14 | 2-26M FS-11d, 2811001 FS-20d, 1363015b, 13461045M, 2363015aa, 1363015aa | 0d |  |  | 8/5 M-F w/JLAB Holidays ReBaseline |  | HARWOOD L | 1 | 1 | 3 | LEIGH H |  | ACCL | 4 |  |  |  |  |  |  |  |  |  |  |  |  |  |  |  |  |  |  | 12-029 |  |  |  | 12-025 | PR | 11-026 |  |  |
| 3A-46M |  | H-C BL Installtn Comptd | milestone | 0d | 2013-11-15 | 2013-11-15 | 23427057, 13427057, 13221115 | 122d | 49d |  | 8/5 M-F w/JLAB Holidays ReBaseline |  | HARWOOD L | 1 | 1 | 3 | LEIGH H |  | ACCL | 4 |  |  |  |  |  |  | 12-018F |  | 10-065 | 12-035 |  |  |  |  |  |  |  |  | 12-029F |  |  |  | 12-025 | PR |  |  |  |
| 3A-42M |  | MPS Installtn Comptd | milestone | 0d | 2013-12-20 | 2013-12-20 | 13641100M, 13641080M, 13641045M, 23641045M, 23641080M | 100d | 28d |  |  |  | HARWOOD L | 1 | 1 | 3 | LEIGH H |  | ACCL | 4 |  |  |  |  |  |  |  |  |  |  |  |  |  |  | 12-037 |  |  |  |  |  |  |  |  | PR |  |  |  |
| 3A-49M |  | PSS Installtn Comptd | milestone | 0d | 2014-01-15 | 2014-01-15 | 13643165, 23643105a, 23643140a, 13643172M, 23643117, 13643105, 13643070, 23643105, 13643345, 23643165, 23643170M, 23643117a, 13643075, 13643140, 13643170M, 13643120, 23643140, 23643117b | 61d | 40d |  |  |  | HARWOOD L | 1 | 1 | 3 | LEIGH H |  | ACCL | 4 |  |  |  |  |  | 10-066 |  |  |  |  |  |  |  |  | 12-037 |  |  |  |  |  |  |  |  | PR |  | 10-070 |  |
| 3A-48M |  | Trim Supply Installtn Comptd | milestone | 0d | 2014-02-04 | 2014-02-04 | 13224110, 23223015, 13223025, 23223051Q FS-15d, 23223060a, 13224003LOE FS-100d, 13223015, 23223025, 23223015a, 23224003LOE FS-100d, 13223060, 2813224005, 23223025a | 35d | 0d |  |  |  | HARWOOD L | 1 | 1 | 3 | LEIGH H |  | ACCL | 4 |  | 12-028 | 10-028 |  |  |  |  |  |  |  |  |  |  |  |  |  |  |  |  |  |  |  |  | PR |  |  |  |
| 3A-53M |  | H-D BL Installtn Comptd | milestone | 0d | 2014-02-07 | 2014-02-07 | 2365035M, 23458065a, 1365035M, 1365065M, 2365065M, 2532020, 2367025aa, 1363020b, 13458065, 23458065, 13221115, 1366055M, 1363020a, 2366055M, 13643185M, 2367025a, 2562435 | 46d | 0d |  | 8/5 M-F w/JLAB Holidays ReBaseline |  | HARWOOD L | 1 | 1 | 3 | LEIGH H |  | ACCL | 4 |  |  |  |  |  |  | 12-018F |  |  | 12-035 |  |  |  |  |  |  |  |  | 12-029F |  |  |  | 12-025 | PR | 11-026 |  | 12-026 |

Notes:
- 32-02M: Scope: CHL Final Design Review / Explanation: Orginial Finish date was on or before 31 August 09. Date / was changed by CR09-053, which details when this milestone will be / complete. New date 31 Jan 10.
- 3A-04M: Explanation: IPL from 6 GeV / 53311010M
- 3A-19M: Explanation: IPL to 6 GeV 53417004M, 53417070M, / 53417145M, 53417215M, 53417285M and 53417360M
- 3A-52M: Explanation: IPL from 6 GeV 534211000M, 534212005M / and 534214010M
- 3A-56M: Explanation: IPL from 6 GeV 534212005M, 534214010M / and 534211000M
- 3A-54M: Explanation: IPL from 6 GeV 53411000M, 53411005M / and 53416045M

| ID | WBS | Activity | Type | Duration | Start | Finish | Predecessors | Total float | Free float | Constraint | Calendar | GROP Group | RESP - Responsibility | MILE - Milestone | STRT%COMP for CM EVM | FNSH%COMP for CM EVM | Milestone Level | Profile change | CAM RESPONSIBLE | CR 09-044 | CR 10-061 | CR 12-015 | 12 GeV 2nd level Critical Path | CIVIL CRITICAL MILESTONES | CR 10-059 | CR 11-020 | CR 10-032 | CR 10-033 | CR 10-021 | CR 11-044 | CR 10-020 | CR 11-001 | PPEP Date | HALL D Related Milestones | Inter Project Link (IPL) | CR 09-028 | CR 09-028 Repair | CR 11-004 | CR 10-048 | CR 11-026 | CR 11-046 | CR 12-012 | CR 12-036 | CR 13-006 | CR 11-035 | CR 11-036 | CR 12-025 | Post Rebaseline | Original Activity ID Rebaseline | 12 GeV 1st level Critical Path | CR 11-006 | CR 12-021 | CR 12-024 | CR 13-002 | CR 10-069 | CR 12-054 |
| --- | --- | --- | --- | --- | --- | --- | --- | --- | --- | --- | --- | --- | --- | --- | --- | --- | --- | --- | --- | --- | --- | --- | --- | --- | --- | --- | --- | --- | --- | --- | --- | --- | --- | --- | --- | --- | --- | --- | --- | --- | --- | --- | --- | --- | --- | --- | --- | --- | --- | --- | --- | --- | --- | --- | --- | --- |
|  | 1.03C | **1.03C LEVEL 3 CIVIL MILESTONES** |  |  | 2007-11-30 | 2013-08-30 |  |  |  |  |  |  |  |  |  |  |  |  |  |  |  |  |  |  |  |  |  |  |  |  |  |  |  |  |  |  |  |  |  |  |  |  |  |  |  |  |  |  |  |  |  |  |  |  |  |  |
| 3C-01M |  | Civil A-E Dsgns of H-D Complex & CHL Addition are Comptd. | milestone | 0d | 2007-11-30 | 2007-11-30 | 1243040M | 15d | 163d | finish on or before 2007-12-31 |  | CVL | YASKY R | 2 | 1 | 1 | 3 | C | REBECCA Y |  |  |  |  |  |  |  |  |  |  |  |  |  |  |  |  |  |  |  |  |  |  |  |  |  |  |  |  |  |  |  |  |  |  |  |  |  |
| 3C-02M |  | Civil Dsgn Work by Facilt's Management for the Accel projects (does not Include CHL) is Comptd. | milestone | 0d | 2008-07-09 | 2008-07-09 | 1241030, 1241110, 1241190, 1241070, 1241150 | 16d | 0d | finish on or before 2008-07-31 |  | CVL | YASKY R | 2 | 1 | 1 | 3 |  | REBECCA Y |  |  |  |  |  |  |  |  |  |  |  |  |  |  |  |  |  |  |  |  |  |  |  |  |  |  |  |  |  |  |  |  |  |  |  |  |  |
| 3C-04M |  | Civil Constr Contract Award of the CHL Bldng Addition, Doesn't Include the Elect & Cooling Water Utility distrib. | milestone | 0d | 2009-01-16 | 2009-01-16 | 1621005 | 72d | 0d | finish on or before 2009-04-30 |  | CVL | YASKY R | 2 | 1 | 1 | 3 |  | REBECCA Y |  |  |  |  |  |  |  |  |  |  |  |  |  |  |  |  |  |  |  |  |  |  |  |  |  |  |  |  |  |  |  |  |  |  |  |  |  |
| 3C-03M |  | Civil Constr Contract Award for P- I of the H-D Complex conventional Facilt's. | milestone | 0d | 2009-02-02 | 2009-02-02 | 16331005 | 62d | 0d | finish on or before 2009-04-30 |  | CVL | YASKY R | 2 | 1 | 1 | 3 |  | REBECCA Y |  |  |  |  |  |  |  |  |  |  |  |  |  |  |  |  |  |  |  |  |  |  |  |  |  |  |  |  |  |  |  |  |  |  |  |  |  |
| 3C-06M |  | Civil Sitework & Utility Distrbtn Associated with P- I of the H-D complex Comptd. | milestone | 0d | 2010-05-28 | 2010-05-28 | 16331010A, 16331010C, 16331010F, 16331010G, 16331010L FS-23d, 16331010H, 16331010J, 16331010K, 16331010, 16331010D, 16331010B | 1382d | 125d |  |  | CVL | YASKY R | 2 | 1 | 1 | 3 |  | REBECCA Y | 09-044 | 10-061 | 12-015 |  |  |  |  |  |  |  |  |  |  |  |  |  |  |  |  |  |  |  |  |  |  |  |  |  |  |  |  |  |  |  |  |  |  |
| 3C-09M |  | Start Installtn, RFE of H-D Cryo Plant Bldng Comptd. | milestone | 0d | 2011-02-28 | 2011-02-28 | 16332040F | 87d | 15d | finish on or before 2011-06-30 |  | CVL | YASKY R | 2 | 1 | 1 | 3 |  | REBECCA Y |  |  |  | 2 | CVL | 10-059 | 11-020 |  |  |  |  |  |  |  |  |  |  |  |  |  |  |  |  |  |  |  |  |  |  |  |  |  |  |  |  |  |  |
| 3C-11M |  | Civil Constr Electrical Distrbtn Upgrades at the N&S Access Bldngs & at the N&S Linac bldgs Comptd . | milestone | 0d | 2011-03-18 | 2011-03-18 | 16122025, 16111030M | 278d | 642d | finish on or before 2012-04-30 |  | CVL | YASKY R | 2 | 1 | 1 | 3 |  | REBECCA Y |  |  |  |  |  |  |  | 10-032 | 10-033 |  |  |  |  |  |  |  |  |  |  |  |  |  |  |  |  |  |  |  |  |  |  |  |  |  |  |  |  |
| 3C-07M |  | Civil Constr Elect & Cooling Water Utility Distrbtn to Supprt CHL#2 Comptd. | milestone | 0d | 2011-05-27 | 2011-05-27 | 16222035M, 16222030 | 23d | 87d | finish on or before 2011-06-30 |  | CVL | YASKY R | 2 | 1 | 1 | 3 |  | REBECCA Y |  |  |  |  |  |  |  |  |  | 10-021 |  |  |  |  |  |  |  |  |  |  |  |  |  |  |  |  |  |  |  |  |  |  |  |  |  |  |  |
| 3C-10M |  | Start Installtn, RFE of Tagger Area portion of the Underground Accel Tunnel Comptd. | milestone | 0d | 2011-11-30 | 2011-11-30 | 16332030, 16332010U | 17d | 81d | finish on or before 2011-12-30 |  | CVL | YASKY R | 2 | 1 | 1 | 3 |  | REBECCA Y |  |  |  |  |  | 10-059 |  |  |  |  | 11-044 |  |  |  |  |  |  |  |  |  |  |  |  |  |  |  |  |  |  |  |  |  |  |  |  |  |  |
| 3C-08M |  | Civil Constr N&S Access Bldng Additions & BSW Service bldng Addition Comptd. | milestone | 0d | 2012-02-21 | 2012-02-21 | 16113025, 16111025 | 49d | 403d | finish on or before 2012-04-30 |  | CVL | YASKY R | 2 | 1 | 1 | 3 |  | REBECCA Y |  |  |  |  |  |  |  |  |  |  |  |  |  |  |  |  |  |  |  |  |  |  |  |  |  |  |  |  |  |  |  |  |  |  |  |  |  |
| 3C-13M |  | Blue Crab End of Occupation | milestone | 0d | 2013-08-30 | 2013-08-30 | 197111110, 197111065, 197111130, 197111105, 197111145, 197111085, 197111059 | 0d |  | mandatory finish 2013-08-30 | 8/5 M-F w/JLAB Holidays ReBaseline |  | YASKY R |  | 1 | 1 | 3 |  | REBECCA Y |  |  |  |  |  |  |  |  |  |  |  | 10-020 | 11-1VA |  |  |  |  |  |  |  |  |  |  |  |  |  |  |  |  |  |  |  |  |  |  |  |  |
|  | 1.03P | **1.03P LEVEL 3 PHYSICS MILESTONES** |  |  | 2009-05-20 | 2016-02-10 |  |  |  |  |  |  |  |  |  |  |  |  |  |  |  |  |  |  |  |  |  |  |  |  |  |  |  |  |  |  |  |  |  |  |  |  |  |  |  |  |  |  |  |  |  |  |  |  |  |  |
| 32-12M |  | H-D Expermntl Equipment Dsgn Comptd | milestone | 0d | 2009-05-20 | 2009-05-20 | 12353045M | 92d |  | finish on or before 2009-09-30 |  |  | YOUNG G |  | 1 | 1 | 3 |  | YOUNG G |  |  |  |  |  |  |  |  |  |  |  |  |  | 2008-06-30 | D |  |  |  |  |  |  |  |  |  |  |  |  |  |  |  |  |  |  |  |  |  |  |
| 3P-23M |  | Hall D Life Safety Systems Operational | milestone | 0d | 2011-09-02 | 2011-09-02 | 16332015 FS-20d | 21d | 20d | finish on or before 2011-10-03 |  |  | YOUNG G |  | 1 | 1 | 3 |  | YOUNG G |  |  |  |  |  |  |  |  |  |  |  |  |  |  |  | IPL | 09-028 | 09-028 | 11-004 |  |  |  |  |  |  |  |  |  |  |  |  |  |  |  |  |  |  |
| 3P-01M |  | Start Expermntl Equipmnt Installtn into H-A | milestone | 0d | 2012-05-07 | 2012-05-07 | 14151005, 14152015 | 5d |  | start on or before 2012-05-14 |  |  | YOUNG G |  | 1 | 1 | 3 |  | YOUNG G |  |  |  |  |  |  |  |  |  |  |  |  |  |  |  |  |  |  |  | 10-048 |  |  |  |  |  |  |  |  |  |  |  |  |  |  |  |  |  |
| 3P-02M |  | Removl of Expermntl Equipmnt Prior to major Installtns of New Equipmnt in H-B is Comptd. | milestone | 0d | 2012-05-14 | 2012-05-14 | 3P-03M | 33d | 0d | finish on or before 2012-06-29 |  |  | YOUNG G |  | 1 | 1 | 3 |  | YOUNG G |  |  |  |  |  |  |  |  |  |  |  |  |  |  |  |  |  |  |  |  | 11-026 |  |  |  |  |  |  |  |  |  |  |  |  |  |  |  |  |
| 3P-03M |  | Start Removl of Expermntl Equipmnt from H-B Prior to major Installtns of New Equipmnt | milestone | 0d | 2012-05-14 | 2012-05-14 | 2-02M | -10d | 0d | start on or before 2012-04-30 |  |  | YOUNG G |  | 1 | 1 | 3 |  | YOUNG G |  |  |  |  |  |  |  |  |  |  |  |  |  |  |  |  |  |  |  |  | 11-026 |  |  |  |  |  |  |  |  |  |  |  |  |  |  |  |  |
| 3P-04M |  | Start Removl of Expermntl Equipmnt from H-C Prior to major Installtns of New Equipmnt | milestone | 0d | 2012-05-14 | 2012-05-14 | 2-02M | 12d | 20d | start on or before 2012-05-31 |  |  | YOUNG G |  | 1 | 1 | 3 |  | YOUNG G |  |  |  |  |  |  |  |  |  |  |  |  |  |  |  |  |  |  |  |  |  |  |  |  |  |  |  |  |  |  |  |  |  |  |  |  |  |
| 3P-07M |  | Start Expermntl Equipmnt Installtn into H-C | milestone | 0d | 2012-05-14 | 2012-05-14 | 2-02M, 14368010M | 233d | 213d |  |  |  | YOUNG G |  | 1 | 1 | 3 |  | YOUNG G |  |  |  |  |  |  |  |  |  |  |  |  |  |  |  |  |  |  |  |  |  | 11-046 | 12-012 | 12-036F | 13-006F |  |  |  |  |  |  |  |  |  |  |  |  |
| 3P-08M |  | Start Expermntl Equipmnt Installtn into H-B | milestone | 0d | 2012-05-14 | 2012-05-14 | 3P-03M, 3P-02M | 119d | 345d | start on or before 2012-10-31 |  |  | YOUNG G |  | 1 | 1 | 3 |  | YOUNG G |  |  |  |  |  |  |  |  |  |  |  |  |  |  |  |  |  |  |  |  |  |  |  |  |  | 11 -035 |  |  |  |  |  |  |  |  |  |  |  |
| 3P-24M |  | Start Hall D Cooldown | milestone | 0d | 2012-11-12 | 2012-11-12 | 13321050, 18241010 FS-14d, 181332000, 13327000 | 8d | 0d | start on or before 2012-11-26 |  |  | YOUNG G |  | 1 | 1 | 3 |  | YOUNG G |  |  |  |  |  |  |  |  |  |  |  |  |  |  |  | IPL | 09-028 | 09-028 | 11-004 |  |  |  |  |  |  |  | 11-036 |  |  |  |  |  |  |  |  |  |  |
| 3P-12M |  | Start E-B Commssng of H-A Detctr's, Electrnc's, & BL Devices | milestone | 0d | 2014-02-28 | 2014-02-28 | 2811019, 2-03M FS+40d | 19d | 0d | start on or after 2014-02-01 | 8/5 M-F w/JLAB Holidays ReBaseline |  | YOUNG G |  | 1 | 1 | 3 |  | YOUNG G |  |  |  |  |  |  |  |  |  |  |  |  |  |  |  |  |  |  |  |  | 11-026 |  |  |  |  |  |  | 12-025 | PR |  |  |  |  |  |  |  |  |
| 3P-25M |  | 10 GeV Beam to Hall D Tagger | milestone | 0d | 2014-03-14 | 2014-03-14 | 3A-53M, 3P-12M, 4A-12M, 23641100, 23641085, 3A-49M | 21d | 259d | finish on or before 2014-04-14 | 8/5 M-F w/JLAB Holidays ReBaseline |  | YOUNG G |  | 1 | 1 | 3 |  | YOUNG G |  |  |  |  |  |  |  |  |  |  |  |  |  |  |  | IPL | 09-028 | 09-028 | 11-004 |  |  |  |  |  |  |  | 11-036 |  | PR | 3P-25M |  |  |  |  |  |  |  |
| 3P-16M |  | Start E-B Commssng of H-D Detctr's, Electrnc's, & BL Devices | milestone | 0d | 2014-11-19 | 2014-11-19 | 2-03M FS+100d, 23611065M, 2-25M FS-120d, 2-12M, 23614045M, 2811064 | 8d | 0d | start on or after 2014-04-01 | 8/5 M-F w/JLAB Holidays ReBaseline |  | YOUNG G |  | 1 | 1 | 3 |  | YOUNG G |  |  |  |  |  |  |  |  |  |  |  |  |  |  | D |  | 09-028 | 09-028 |  |  | 11-026 |  |  |  |  |  |  |  | PR |  | 1 | 11-006 | 12-021 |  |  |  |  |
| 3P-26M |  | Torus Assembled and Tested | milestone | 0d | 2015-10-01 | 2015-10-01 | 24264788M | 17d | 0d |  | 8/5 M-F w/JLAB Holidays ReBaseline |  | YOUNG G |  | 1 | 1 | 3 |  | YOUNG G |  |  |  |  |  |  |  |  |  |  |  |  |  |  |  | IPL | 09-028 | 09-028 | 11-004 |  |  |  |  |  |  |  | 11-036 |  | PR | 3P-26M |  |  |  |  |  |  |  |
| 3P-20M |  | Start E-B Commssng of H-B Detctr's, Electrnc's, & BL Devices | milestone | 0d | 2016-01-28 | 2016-01-28 | 2811034, 2-03M, 2-25M | 36d | 0d | start on or after 2014-10-01 | 8/5 M-F w/JLAB Holidays ReBaseline |  | YOUNG G |  | 1 | 1 | 3 |  | YOUNG G |  |  |  |  |  |  |  |  |  |  |  |  |  |  |  |  |  |  |  |  | 11-026 |  |  |  |  |  |  |  | PR |  |  |  |  | 12-024 | 13-002 |  |  |
| 3P-18M |  | Start E-B Commssng of H-C Detctr's, Electrnc's, & BL Devices | milestone | 0d | 2016-02-02 | 2016-02-02 | 2-25M, 2811049, 24368500, 2-03M | 38d | 0d | start on or after 2014-09-01 | 8/5 M-F w/JLAB Holidays ReBaseline |  | YOUNG G |  | 1 | 1 | 3 |  | YOUNG G |  |  |  |  |  |  |  |  |  |  |  |  |  |  |  |  | 09-028 | 09-028 |  |  | 11-026 |  | 12-012 | 12-036 |  |  |  |  | PR |  |  |  |  |  |  | 10-069 | 12-054 |
| 3P-22M |  | E-B Commssng of H-C Detctr's, Electrnc's, & BL Devices Comptd | milestone | 0d | 2016-02-08 | 2016-02-08 | 2812035, 2823X000, 2811050 | 42d | 0d |  |  |  | YOUNG G |  | 1 | 1 | 3 |  | YOUNG G |  |  |  |  |  |  |  |  |  |  |  |  |  |  |  | IPL | 09-028 | 09-028 |  |  | 11-026 |  | 12-012 | 12-036 |  |  |  |  | PR |  |  |  |  |  |  |  | 12-054 |
| 3P-21M |  | E-B Commssng of H-B Detctr's, Electrnc's, & BL Devices Comptd | milestone | 0d | 2016-02-10 | 2016-02-10 | 14234020LOE, 2811035, 2812020, 2822X000 | 40d | 0d |  |  |  | YOUNG G |  | 1 | 1 | 3 |  | YOUNG G |  |  |  |  |  |  |  |  |  |  |  |  |  |  |  | IPL | 09-028 | 09-028 |  |  | 11-026 |  |  |  |  |  |  |  | PR |  |  |  |  | 12-024 | 13-002 |  |  |

Notes:
- 3C-02M: Scope: Design / work by Facilities Management for the Accelerator projects (does not include / CHL) is complete.
- 3C-04M: Scope: Construction / contract award of the CHL building addition. D oesn't include the elect and cooling / water utility distrib.
- 3C-03M: Scope: The / construction contract award for Phase I of the Hall D Complex conventional / facilities. Phase I includes / Experimental Hall D, Counting House foundation for structural support of Hall D, / and preliminary sitework and utilities.
- 3C-06M: Scope: Complete / the sitework and utility distribution associated with Phase I of the Hall D / complex. Includes clearing trees, / contractor mobilization, and electrical distribution to Experimental Hall / D.
- 3C-09M: Scope: Civil / construction completion of Hall D Cryo Plant Building and ready for equipment / installation to start.
- 3C-11M: Scope: Construction / completion of the electrical distribution upgrades at the N&S Access / buildings and at the N&S Linac bldgs.
- 3C-07M: Scope: The / construction completion of the electrical and cooling water utility distribution / to support CHL#2.
- 3C-10M: Scope: Civil / constr completion of the Tagger area portion of the underground Accel tunnel / and RFE installation to start.
- 3C-08M: Scope: Civil / construction completion of the North and South Access building additions and the / BSW Service building addition.
- 32-12M: Scope: Completion of experimental equipment designs for Hall / D / Made level 3 from / level 2 4/11/07 RKC
- 3P-23M: Scope: Complete electron beam commissioning / of Hall C detectors, electronics, and beamline devices / Explanation: IPL from 6 GeV 5333065, 5333070 and 5333075 / Added FY14 Funding Predeccessor with 57.6 weeks lag to bring start date out / to match 6 GeV impact
- 3P-01M: Scope: Begin experimental equipment / installation into Hall A
- 3P-02M: Scope: Removal of experimental equipment / prior to major installations of new equipment in Hall B is / complete.
- 3P-03M: Scope: Begin removal of experimental / equipment from Hall B prior to major installations of new / equipment
- 3P-04M: Scope: Begin removal of experimental / equipment from Hall C prior to major installations of new / equipment
- 3P-07M: Scope: Begin experimental equipment / installation into Hall C
- 3P-08M: Scope: Begin experimental equipment / installation into Hall B
- 3P-24M: Scope: Complete electron beam commissioning / of Hall C detectors, electronics, and beamline devices / Explanation: IPL from 6 GeV 5333065, 5333070 and 5333075 / Added FY14 Funding Predeccessor with 57.6 weeks lag to bring start date out / to match 6 GeV impact
- 3P-12M: Scope: Begin electron beam commissioning of / Hall A detectors, electronics, and beamline devices
- 3P-25M: Scope: Complete electron beam commissioning / of Hall C detectors, electronics, and beamline devices / Explanation: IPL from 6 GeV 5333065, 5333070 and 5333075 / Added FY14 Funding Predeccessor with 57.6 weeks lag to bring start date out / to match 6 GeV impact
- 3P-16M: Scope: Begin electron beam commissioning of / Hall D detectors, electronics, and beamline devices
- 3P-26M: Scope: Complete electron beam commissioning / of Hall C detectors, electronics, and beamline devices / Explanation: IPL from 6 GeV 5333065, 5333070 and 5333075 / Added FY14 Funding Predeccessor with 57.6 weeks lag to bring start date out / to match 6 GeV impact
- 3P-20M: Scope: Begin electron beam commissioning of / Hall B detectors, electronics, and beamline devices
- 3P-18M: Scope: Begin electron beam commissioning of / Hall C detectors, electronics, and beamline devices
- 3P-22M: Scope: Complete electron beam commissioning / of Hall C detectors, electronics, and beamline devices / Explanation: IPL from 6 GeV 5333065, 5333070 and 5333075 / Added FY14 Funding Predeccessor with 57.6 weeks lag to bring start date out / to match 6 GeV impact
- 3P-21M: Scope: Complete electron beam commissioning / of Hall B detectors, electronics, and beamline devices / Explanation: IPL from 6 GeV 5333065, 5333070 and 5333075 / Added FY14 Funding Predeccessor with 57.6 weeks lag to bring start date out / to match 6 GeV impact

| ID | WBS | Activity | Type | Duration | Start | Finish | Predecessors | Complete | Total float | Free float | Constraint | Calendar | Planned FinishUDF | RESP - Responsibility | STRT%COMP for CM EVM | FNSH%COMP for CM EVM | Milestone Level | CAM RESPONSIBLE | GROP Group | MILE - Milestone | CR 07-015 | CR 07-024 | Profile change | CR 07-033 | CR 08-002 | 12 GeV 5th level Critical Path | Inter Project Link (IPL) | CR 10-028 | CR 10-031 | CR 10-064 | CR 10-066 | CR 10-030 | CR 10-070 | CR 12-018 | CR 12-028 | CR 12-029 | Post Rebaseline | CR 12-025 | CR 10-065 | CR 11-026 | CR 12-037 | CR 12-026 | CR 12-050 | Original Activity ID Rebaseline |
| --- | --- | --- | --- | --- | --- | --- | --- | --- | --- | --- | --- | --- | --- | --- | --- | --- | --- | --- | --- | --- | --- | --- | --- | --- | --- | --- | --- | --- | --- | --- | --- | --- | --- | --- | --- | --- | --- | --- | --- | --- | --- | --- | --- | --- |
|  | 1.03R | **1.03R LEVEL 3 REVIEW MILESTONES** |  |  | 2006-06-27 | 2009-09-30 |  |  |  |  |  |  |  |  |  |  |  |  |  |  |  |  |  |  |  |  |  |  |  |  |  |  |  |  |  |  |  |  |  |  |  |  |  |  |
| 3R-1M |  | FY06 Lehman Review | milestone | 0d | 2006-06-27 A | 2006-06-27 A |  | 100% |  |  |  |  | 2006-06-27 | RODE C | 1 | 1 | 3 | CLAUS R |  |  |  |  |  |  |  |  |  |  |  |  |  |  |  |  |  |  |  |  |  |  |  |  |  |  |
| 3R-2M |  | CD-2 Review IPR | milestone | 0d | 2007-06-29 | 2007-06-29 | 2-19M, 2-20M, 11111000M, 2-21M, 121411015M |  | 0d |  | mandatory finish 2007-06-29 |  | 2007-06-29 | DOE | 1 | 1 | 3 | CLAUS R | CDS | 0 | 07-015 |  |  |  |  |  |  |  |  |  |  |  |  |  |  |  |  |  |  |  |  |  |  |  |
| 3R-3M |  | CD-2 Review EIR | milestone | 0d | 2007-08-15 | 2007-08-15 | 1212121130M, 3R-2M |  | 0d |  | mandatory finish 2007-08-15 |  | 2007-08-15 | DOE | 1 | 1 | 3 | CLAUS R | CDS | 0 |  |  |  |  |  |  |  |  |  |  |  |  |  |  |  |  |  |  |  |  |  |  |  |  |
| 3R-07M |  | EVMS Assessment | milestone | 0d | 2007-09-17 | 2007-09-17 | 3R-2M |  | 0d |  | mandatory start 2007-09-17 |  |  | RODE C | 1 | 1 | 3 | CLAUS R |  |  |  | 07-024 | C |  |  |  |  |  |  |  |  |  |  |  |  |  |  |  |  |  |  |  |  |  |
| 3R-08M |  | OECM EVMS Contractor CERTIFICATION Completed | milestone | 0d | 2008-01-31 | 2008-01-31 | 2-22M |  | 105d | 169d | finish on or before 2008-06-30 |  |  | RODE C | 1 | 1 | 3 | CLAUS R |  |  |  |  |  | 07-033 | 08-002 |  |  |  |  |  |  |  |  |  |  |  |  |  |  |  |  |  |  |  |
| 3R-05M |  | CD-3 Review IPR | milestone | 0d | 2008-07-31 | 2008-07-31 | 1135025, 1132890M FS-45d, 11111005RKC, 12225045, 1152005A, 1154001RKC, 1155001RKC, 1132800M FS-45d, 1141005RKC5, 1251006RKC, 121221140, 1212111170, 12224005, 121221120, 12131.10010, 1152001RKC, 1132865M FS-45d, 1132895, 1132841 FS-45d, 1132021RKC, 121221145, 121111010M, 121613027, 12163170, 121642170, 2-05M, 2-23M, 3C-01M, 1155020, 123221908LOE, 121224999, 12166027, 2-24M, 19005RKC, 1155025, 1155030, 1132875M FS-45d, 1242040M, 12162027, 12131.04020, 19001RKC, 1152040, 1154025, 1141005RKC, 121223050, 12165027, 12131.03010, 12131.11010, 1132831M FS-45d, 1112015M, 121221135, 12167027, 121614027, 121611041, 121612022 |  | 0d |  | mandatory finish 2008-07-31 |  |  | RODE C | 1 | 1 | 3 | CLAUS R |  |  |  |  | C |  |  | 5 |  |  |  |  |  |  |  |  |  |  |  |  |  |  |  |  |  |  |
| 3R-06M |  | PED Complete (30 Sep 09) (IPL 521224170M) | milestone | 0d | 2009-09-30 | 2009-09-30 | 12361010, 12223040M, 1222241035M, 12222065, 1222223041M, 122322015b, 122325020, 122324015, 1212122110M, 1212127065M, 1211020M, 121138060, 121614035M, 12162040M, 12156040M, 12156045, 121324000, 12131.09000, 121411110M, 32-12M, 1241035M, 12223045, 12232020, 122323015, 122311055a, 122312095, 1212124170, 1212122170, 1212123050, 1212126170, 1212112020, 1211020M10, 12166035, 121643140, 12131.07015b, 121416005a, 121456999, 1233039, 1233040M, 12353045M, 12226010a, 12225020, 12222015M, 12222055, 12222060, 12236040, 122311056, 1212127170, 1212121170, 12165030, 12163050M, 12156035, 12131.08000, 121416010, 121454015a, 126080M, 12323040M, 12351055M, 12226020a, 12222055b, 12222000a, 1222223040, 122153010, 1212125025M, 1212123055M, 121613040M, 121611055M, 121643045A, 121642010A, 121322000, 12131.03020, 12131.07015, 12361005, 12321018M, 12225040, 12222015a, 12236025, 12236060, 121221150, 1212123170, 1212121095, 1212112145M, 1211020M5, 12115005M, 121113005, 121643080A, 121643010A, 121642015A, 12151020M, 121323000, 121414016, 121446999, 12222070, 12222080, 12236830LOE, 122152020, 1212121145M, 1211020M15, 121114010M, 12167028, 121612030, 121612035, 121643065A, 121414015a, 121425015, 12322018M, 1234180M, 12226015a, 12225050, 12222045, 1222232030, 12232015, 12236020, 1212127060, 1212113170, 12165035, 121414020a, 121434999, 12222035M, 12236015b, 12236010b, 121223060a, 12156002, 121325000, 12131.04025 |  | 0d |  | mandatory finish 2009-09-30 |  |  | RODE C | 1 | 1 | 3 | CLAUS R |  |  |  |  | C |  |  |  | IPL |  |  |  |  |  |  |  |  |  |  |  |  |  |  |  |  |  |
|  | 1.04A | **1.04A LEVEL 4 ACCELERATOR MILESTONES** |  |  | 2011-01-04 | 2014-03-14 |  |  |  |  |  |  |  |  |  |  |  |  |  |  |  |  |  |  |  |  |  |  |  |  |  |  |  |  |  |  |  |  |  |  |  |  |  |  |
| 4A-03M |  | Start HPA Installtn | milestone | 0d | 2011-01-04 | 2011-01-04 | 1321122050 FS+182d, 3A-01M |  | 168d | 0d |  |  |  | HARWOOD L | 1 | 1 | 4 | LEIGH H | ACCL | 4 |  |  |  |  |  |  |  | 10-028 | 10-031 | 10-064 | 10-066 |  |  |  |  |  |  |  |  |  |  |  |  |  |
| 4A-01M |  | Start Precurser Maint Down (6 mo dur, ~1yr before Installtn Down) (IPL534213075,534213105,534213135,53427000M,5348065M) | milestone | 0d | 2011-05-13 | 2011-05-13 | 13434007, 13427063LOE, 13427180a, 13427055, 13421095, 13421046ab, 13433015, 13421046b, 13421090, 13456045 |  | 0d |  | mandatory start 2011-05-13 |  |  | HARWOOD L | 1 | 1 | 4 | LEIGH H |  |  |  |  |  |  |  |  | IPL |  |  |  |  | 10-030 |  |  |  |  |  |  |  |  |  |  |  |  |
| 4A-04M |  | End of Precurser Maint Down (6 mo dur, ~1 yr before Installtn Down) | milestone | 0d | 2011-11-11 | 2011-11-11 | 13427060, 131502005a FS+15d, 14368171, 14341007, 13427062LOE, 13436035, 13427115M, 14368170, 13221093a |  | 0d |  | mandatory finish 2011-11-11 |  |  | HARWOOD L | 1 | 1 | 4 | LEIGH H |  |  |  |  |  |  |  |  |  |  |  |  |  |  |  |  |  |  |  |  |  |  |  |  |  |  |
| 4A-07M |  | Linac Installtn Comptd | milestone | 0d | 2013-10-11 | 2013-10-11 | 1331.1005, 2331.1005, 1331.02066, 1331.11000, 181331000, 3A-47M, 3A-41M, 1331.02080 |  | 34d | 12d |  | 8/5 M-F w/JLAB Holidays ReBaseline |  | HARWOOD L | 1 | 1 | 4 | LEIGH H | ACCL | 4 |  |  |  |  |  |  |  |  |  |  | 10-066 |  | 10-070 | 12-018 | 12-028 | 12-029F | PR |  |  |  |  |  |  |  |
| 4A-10M |  | Start Accel Hot Chkout | milestone | 0d | 2013-10-15 | 2013-10-15 | 3C-11M, 13221095, 13213020M, 3A-54M FS-25d, 3A-52M, 3A-58M, 4A-09M FS-20d, 9-140M FS+10d, 23454055 FS-20d, 1351080, 1352035, 2367055 FS-34d, 1367055, 3A-10M, 13643185M, 23454055b FS-20d, 1363014a, 1363025b, 23224100a FS-40d, 1366030M, 1367025a, 13454055, 13224100, 13221097LOE, 23213020M FS-45d, 1363025a, 3A-41M, 3A-56M, 23224100 FS-40d, 1353095, 13642030M, 13643175M, 13612035M, 3A-47M FS-20d, 3A-40M, 13454050, 13611065M, 23454055a FS-20d |  | 0d |  |  | 8/5 M-F w/JLAB Holidays ReBaseline |  | HARWOOD L | 1 | 1 | 4 | LEIGH H | ACCL | 4 |  |  |  |  |  |  | IPL |  |  |  |  |  |  |  |  |  | PR | 12-025 |  |  |  |  |  |  |
| 4A-09M |  | I&C/Sfty for Accelerator Installtn Comptd | milestone | 0d | 2013-10-25 | 2013-10-25 | 2365065M, 23643170M, 23613035M, 23612035M |  | 11d | 2d |  | 8/5 M-F w/JLAB Holidays ReBaseline |  | HARWOOD L | 1 | 1 | 4 | LEIGH H | ACCL | 4 |  |  |  |  |  |  |  |  |  |  |  |  |  | 12-018F |  |  | PR |  | 10-065 | 11-026 | 12-037 |  |  |  |
| 4A-08M |  | Accelerator Beam Transport Comptd | milestone | 0d | 2013-10-29 | 2013-10-29 | 3A-52M, 3A-56M, 3A-54M |  | 22d | 0d |  | 8/5 M-F w/JLAB Holidays ReBaseline |  | HARWOOD L | 1 | 1 | 4 | LEIGH H | ACCL | 4 |  |  |  |  |  |  |  |  |  |  |  |  |  | 12-018F |  | 12-029F | PR |  | 10-065 |  |  | 12-026 |  |  |
| 4A-06M |  | Pwr (Mag) Installtn Comptd | milestone | 0d | 2014-02-04 | 2014-02-04 | 2-25M FS-180d, 3A-48M |  | 35d | 17d |  |  |  | HARWOOD L | 1 | 1 | 4 | LEIGH H | ACCL | 4 |  |  |  |  |  |  |  | 10-028 |  |  |  |  |  | 12-018F |  | 12-029 | PR |  |  |  |  |  | 12-050 |  |
| 4A-11M |  | Beam Transport to Halls Comptd | milestone | 0d | 2014-02-07 | 2014-02-07 | 3A-44M, 3A-46M, 3A-43M, 3A-53M, 3A-42M |  | 73d | 55d |  | 8/5 M-F w/JLAB Holidays ReBaseline |  | HARWOOD L | 1 | 1 | 4 | LEIGH H | ACCL | 4 |  |  |  |  |  |  |  |  |  |  |  |  |  | 12-018F |  | 12-029F | PR |  | 10-065 |  |  | 12-026 |  | 4A-11M |
| 4A-12M |  | I&C/Sfty Installtn Comptd | milestone | 0d | 2014-03-14 | 2014-03-14 | 23643280, 23641100M, 2-25M FS-120d, 2365035M, 23643185M, 23642030M |  | 21d | 0d |  | 8/5 M-F w/JLAB Holidays ReBaseline |  | HARWOOD L | 1 | 1 | 4 | LEIGH H | ACCL | 4 |  |  |  |  |  |  |  |  |  |  |  |  |  | 12-018F |  |  | PR |  | 10-065 | 11-026 | 12-037 |  |  | 4A-12M |
|  | 1.04P | **1.04P Level 4 PHYSICS MILESTONE** |  |  |  |  |  |  |  |  |  |  |  |  |  |  |  |  |  |  |  |  |  |  |  |  |  |  |  |  |  |  |  |  |  |  |  |  |  |  |  |  |  |  |
|  | 1.09FA | **1.09FA LEVEL 9 FUNDING AVAILABLE MILESTONES** |  |  | 2006-10-02 | 2014-10-01 |  |  |  |  |  |  |  |  |  |  |  |  |  |  |  |  |  |  |  |  |  |  |  |  |  |  |  |  |  |  |  |  |  |  |  |  |  |  |
| 9-070M |  | FY07 Funds Available | milestone | 0d | 2006-10-02 | 2006-10-02 |  |  | 0d |  | mandatory start 2006-10-01 |  | 2006-10-02 | RODE C | 1 | 1 | 9 | CLAUS R |  |  |  |  |  |  |  |  |  |  |  |  |  |  |  |  |  |  |  |  |  |  |  |  |  |  |
| 9-080M |  | FY08 Funds Available | milestone | 0d | 2007-10-01 | 2007-10-01 |  |  | 0d |  | mandatory start 2007-10-01 |  |  | RODE C | 1 | 1 | 9 | CLAUS R |  |  |  |  |  |  |  |  |  |  |  |  |  |  |  |  |  |  |  |  |  |  |  |  |  |  |
| 9-090M |  | FY09 Funds Available | milestone | 0d | 2008-10-01 | 2008-10-01 |  |  | 0d |  | mandatory start 2008-10-01 |  |  | RODE C | 1 | 1 | 9 | CLAUS R |  |  |  |  |  |  |  |  |  |  |  |  |  |  |  |  |  |  |  |  |  |  |  |  |  |  |
| 9-150M |  | End of R&D Funds | milestone | 0d | 2008-10-01 | 2008-10-01 | 1152040, 1135025, 1132831M, 1132875M, 11114070M, 1152035, 1154040, 1152055, 1154025, 1155005A, 1132897, 1132900, 1141015, 1141011, 1132865M, 1132815, 1132800M, 1154060, 1141005RKC, 117908LOE, 1152030, 1154045, 1114010, 1141005RKC5, 1154055, 1155020, 1132895, 1132905, 1132890M, 1142030, 1141012, 1154050, 1155010A, 1155025, 1155030, 1132851M |  | 0d |  | mandatory start 2008-10-01 |  |  | RODE C | 1 | 1 | 9 | CLAUS R |  |  |  |  |  |  |  |  |  |  |  |  |  |  |  |  |  |  |  |  |  |  |  |  |  |  |
| 9-100M |  | FY10 Funds Available | milestone | 0d | 2009-10-01 | 2009-10-01 | 15221190, 15221012A, 15221185, 15221310, 15221191, 14312010a, 14312010, 14312011, 14312002 |  | 0d |  | mandatory start 2009-10-01 |  |  | RODE C | 1 | 1 | 9 | CLAUS R |  |  |  |  |  |  |  |  |  |  |  |  |  |  |  |  |  |  |  |  |  |  |  |  |  |  |
| 9-110M |  | FY11 Funds Available | milestone | 0d | 2010-10-01 | 2010-10-01 | 15212075, 1102231000, 11022325000, 11022321000, 15222025, 11022324000, 15222110, 16223008, 11022322000, 15212070, 16331017, 11022323000 |  | 0d |  | mandatory start 2010-10-01 |  |  | RODE C | 1 | 1 | 9 | CLAUS R |  |  |  |  |  |  |  |  |  |  |  |  |  |  |  |  |  |  |  |  |  |  |  |  |  |  |
| 9-120M |  | FY12 Funds Available | milestone | 0d | 2011-10-03 | 2011-10-03 | 13322005, 1563030, 13325005, 13326005, 13323010, 13221010J, 1316010, 13324010, 13322006, 142211020a, 142213133a, 142211010a |  | 0d |  | mandatory start 2011-10-01 |  |  | RODE C | 1 | 1 | 9 | CLAUS R |  |  |  |  |  |  |  |  |  |  |  |  |  |  |  |  |  |  |  |  |  |  |  |  |  |  |
| 9-130M |  | FY13 Funds Available | milestone | 0d | 2012-10-01 | 2012-10-01 | 13222061, 13221125A, 132127040, 14212025, 13463012, 1563006, 14212012E, 14211085, 14211012E, 13224053, 13221021, 14212005sA, 13422065, 13223035A, 132122020f, 1563017a, 1563016, 1563025, 1563011, 14312034, 14324003a, 13221021A, 13221026, 13414028, 14321900a, 132121060f, 1321122210 |  | 0d |  | mandatory start 2012-10-01 |  |  | RODE C | 1 | 1 | 9 | CLAUS R |  |  |  |  |  |  |  |  |  |  |  |  |  |  |  |  |  |  |  |  |  |  |  |  |  |  |
| 9-140M |  | FY14 Funds Available | milestone | 0d | 2013-10-01 | 2013-10-01 | 1-5M, 1961010, 1622000, 16332055, 16331040, 16111035, 1131010, 1135030, 13447040, 13224055, 132124015, 132125025, 1331.07005, 13325020, 1351950, 131137055, 131115020, 13641950, 13642913LOE, 13643950, 1365950, 12226025, 1212113175, 1212112150, 121134025, 121135025, 12115010, 121641175, 121642175, 12131.10015, 12131.01010, 121441015, 181331005, 18223025, 182443025, 182432055, 1547125, 15231055, 15213010, 15213015, 15221182, 1562210, 1562225, 1562120, 1562690, 15311013E, 1532010a, 15512055, 15512120, 15511120, 14264308, 142241555, 142241255, 142241530, 142241560, 142211370, 142211870, 142211855, 142211800, 142211520, 142213342, 142231325, 142231005, 142231014, 142231265a, 142232620, 142232232, 142232640, 142232390, 142232227, 142223017, 142223120, 142223515, 14231030, 14233005, 14271085, 142762000, 142781000, 14243015, 14243005, 14247065, 14368333, 14368027, 14368510, 14342045, 14341070, 14341110, 14311086g, 14312913LOE, 14328010b, 14324005, 14324003, 14355035, 14132913LOE, 2-11M, 3C-08M, 16113035, 16122035, 171913LOEA, 13451950, 13222240, 13223130, 132122035, 132111914LOE, 1331.03005, 1331.01115, 13326020, 1312000, 131138070, 131131025, 131139030, 131133135, 131114135, 13643913LOE, 13611085, 13611950, 1362035M, 123211060, 123213015, 1243060, 1212127175, 121133025, 121138065, 121124025, 121121015, 121125025, 12165040, 121322005, 12131.11015, 121454020, 1813221000, 18223005, 18223015, 182446025, 182431010, 182432040, 182432000, 182432075, 182432045, 182432060, 182432070, 182432030, 182432005, 1546540, 1547205, 1547190, 1541120, 1541080, 1542055, 1544080, 15231015, 15231150, 15213001a, 1562140a, 1562345, 1562250, 1532013E, 1553110, 15511100, 142241647c, 142241375a, 142242225, 142242135a, 142242245, 142211020, 142211013E, 142213012E, 142231430a, 142231015, 142231330a, 142232655, 142232247, 142232615, 142232255, 14233075, 14273015, 14273020, 1427.10000, 14368383, 14362950, 14363035, 14364040, 14364055, 1433015, 14341090, 14341115a, 14341000, 14341050, 14314115, 14312005, 14312042, 14328005b, 14328010a, 14352000a, 14354030, 14355010, 14153025, 2-18M, 197111150, 195221505, 16112025, 16115025, 1152060, 1154065, 1114015, 117910, 110324000, 13417175, 13427185, 13421950, 13452055, 1331.08005, 1331.09005, 1331.02100, 13327005, 13322015, 1356950, 13613030, 13611913LOE, 13614950, 12332030, 12345010, 123511055, 1222242020, 122311060, 122152025, 1212123175, 1212121135B, 121131025, 121137025, 121116025, 121111015, 121613045, 12163175, 12152035, 12151025, 12154025, 12155055, 12131.04030, 12131.07020, 121414025, 121432010, 121433010, 121452025, 1811070, 18223000, 182446035, 182432010, 182432050, 1547115, 1548010, 1542013E, 15221057a, 15221160baa, 1562065, 1562255, 1562097, 1562370, 1531033, 1552010, 1552040, 1553017, 1553034a, 15512110a, 15512136, 15511110, 14264545, 14264998, 142242060, 142242165a, 142242125, 142211010, 142211430, 142211470, 142211110, 142211950, 142213322P, 142231013E, 142232305, 142232385, 142232665, 142232265, 142232320P, 142232025, 142223530, 14232030, 14231065, 14231125, 14234025, 14235020, 14271045, 142761000, 142771000, 14251010, 14247006, 14247035, 14365020, 14365055, 14363021b, 14364075, 14341015, 14341045, 14341030, 14321905, 14321015M, 14328015, 14325028, 14323015, 14323005a, 14351025, 14151040, 1951000, 16112035, 19010, 13444950, 13454060, 132127045, 1331.1010, 1315000, 13114025, 131301015, 131302015, 13641913LOE, 13613913LOE, 13611025, 1362950, 123212040, 123222035, 1241200, 122231025, 122254020, 122363025, 122312100, 1252910, 121223065, 121113015, 121115015, 121614040, 121416015, 121451060, 1811001, 18223030, 182443030, 182432085, 182432020, 157030, 1548015, 15231060, 15231120, 15212205, 15213010a, 15211255, 1561170, 1562135, 1562015M, 1562359, 1562393, 1531035, 1531105, 1531005ca, 1532077, 1532075c, 1532210, 1532065c, 1553020, 15512110, 15512170, 14212030, 142241415a, 142241565, 142241535, 142241305a, 142242175, 142211400a, 142211445, 142211115a, 142231275, 142231475, 142232234, 142232180, 142232635, 142232396, 142223022, 14271060, 14366025, 14366007, 14368280LOE, 14368120M, 14362070, 14363065, 14364080, 14341120, 14341095, 14341005, 14315045F, 14312032, 14313220, 14328005ba, 14328005a, 14322015, 14325027c, 14323005b, 14351005, 14353015, 14152030, 2-14M, 3P-08M, 19524000, 16115030, 16115050, 1155035, 111121010, 13416050, 13463055, 13426000, 13425035, 13456050, 13221023B, 13213025, 132123030, 1321122215, 132111950, 132113140, 1331.11005, 131116030, 131121050, 1363030a, 1363913LOE, 1366950, 1367060, 13611025c, 13614015, 1231000, 12353050, 1242045, 122325025, 1212122175, 1212125030, 1212126175, 121132025, 12114010, 121126025, 12153025, 121324005, 12131.05020, 121411120, 121421025, 121456020, 181321060, 182446030, 1546570, 1547195, 1547130, 1548040, 1542060, 1543115, 15231025, 15221057b, 15221160bb, 1562145, 1562413, 1531027, 1532067c, 1532075, 1553033, 1553095, 15512005a, 15512035, 14211095, 14264328, 14264204M, 142241395a, 142241345a, 142241595, 142241550, 142241575, 142242110, 142211160v, 142211105h, 142211540, 142211550, 142213220, 142232625, 142232605, 142232560, 142232525, 142223570, 142223319, 14271090, 14254030, 14241020, 14244040, 14366005, 14363060, 14342050, 14342060, 14341025, 14341100, 14341097, 14315046b, 14312025, 14312950, 14312050c, 14313P4LOE, 14328020, 14324010, 14324015, 14325030, 3R-1M, 195222290, 16333040, 16114035, 1121000, 13441015, 13435020, 13422130, 13221022b, 132121075, 1321121085, 1331.06005, 1353100, 1314000, 131135070, 131113000, 131111025, 13642950, 13613950, 13612950, 123221030, 122212050, 122151015, 1212111175, 121136025, 121114015, 12167030, 12156050, 121323005, 121325005, 12131.03025, 12131.06015, 12131.08010, 12131.09005, 121446010, 1831950, 181332005, 181315030, 18223010, 182446040, 182446005, 18241050, 182432025, 1548035, 15231013E, 15231030, 15231065, 15231002, 15213005, 15221315, 1562140, 1562675, 1562420, 1562275, 1531245, 1552050, 1553055, 1553035, 1553045, 1553060, 1553002, 15512013E, 14261000, 14263000, 142241400a, 142241472, 142241545, 142241382a, 142241405ba, 142241655, 142242215, 142242030, 142242195, 142211410, 142213042M, 142213330b, 142213360, 142232330a, 142232680, 142232295, 142743000, 142751000, 14242065, 14247025, 14365023, 14365035, 14365040, 14368265, 14364060, 14364045, 14364016, 14341060, 14315046, 14315105, 14311950, 14312015, 14312045, 14321910, 14328010ba, 14322020, 14325015, 14325027a, 14353020, 9-150M, 195212265, 1621035, 1132910, 1161000, 1112020, 172913LOE, 13433020, 13436070, 13414105, 13462020, 13458070, 13224115, 1331.12005, 13323025, 1355950, 131134025, 131136070, 131123035, 1363950, 13612913LOE, 13614020, 126085, 12361015, 123232040, 12333025, 122153015, 121221155, 1212121175, 121123015, 121444025, 121422000, 121424015, 18223020, 182443020, 1543142, 1545130, 15231045, 15221159b, 15222115, 1562610LOE, 1562475, 1562061, 1562125, 1563035, 1531140, 1531037, 1531100, 1532075ba, 15512100, 15512175, 14264375, 142241580, 142242165b, 142242010, 142211380, 142211160t, 142211535, 142211185, 142211890, 142213322, 142232370a, 142232650, 142232515, 142232610, 142232546, 142232660, 142232285, 142232555, 142232630, 14233007, 14271030, 14271075c, 142741000, 14252015, 14247005, 14366020, 14366030, 14367010, 14364065, 14364035, 14341075, 14341020a, 14341055, 14315100, 14315043, 14314030a, 14311072a, 143118P4LOE, 14312036, 14313280, 14321900, 14352010, 14354035, 14355015, 2-04M, 3R-06M, 195221510, 16112020a, 1142035, 1141025, 171950, 13446015, 13432020, 13411950, 13461055, 13221140, 13324020, 13321075, 1354950, 1352040, 1316015, 131132035, 131112000, 131122115, 1365913LOE, 12331015, 12224010, 122132015, 1251910, 121224070, 1212124175, 121122015, 12166040, 121611060, 121612040, 12162045, 121643175, 182446045, 182431000, 182432035, 182432015, 182432080, 182432065, 157045, 1548030, 1541150, 1541060, 1543150, 151255, 15231070, 15231020, 1562096, 1562013E, 1562090, 1562005LOE, 1531005c, 1531175, 1532015, 1553030, 1553013E, 15512050, 14264886, 14264202M, 142241410a, 142241527, 142241302, 142241600, 142241540, 142242155, 142242205, 142211130, 142213320, 142213242a, 142213320P, 142231420, 142231330b, 142232645, 142232010, 142232015, 142232690, 142223037, 142223575, 14231105, 14231095, 14271025Q, 142791000, 14365025, 14366010, 14368028, 14362065, 14363025, 14341035, 14341105, 14341010, 14341040, 14315037b, 14314100, 14312020, 14321900b, 14322010, 14322013, 14325010, 14325027b, 14323020, 14354025, 18223035, 182431015, 182432090 |  | 0d |  | mandatory start 2013-10-01 | 8/5 M-F w/JLAB Holidays ReBaseline |  | RODE C | 1 | 1 | 9 | CLAUS R |  |  |  |  |  |  |  |  |  |  |  |  |  |  |  |  |  |  | PR |  |  |  |  |  |  |  |
| 9-155M |  | FY15 Funds Available | milestone | 0d | 2014-10-01 | 2014-10-01 |  |  | 0d |  | mandatory start 2014-10-01 | 8/5 M-F w/JLAB Holidays ReBaseline |  | RODE C | 1 | 1 | 9 | CLAUS R |  |  |  |  |  |  |  |  |  |  |  |  |  |  |  |  |  |  | PR |  |  |  |  |  |  |  |

Notes:
- 3R-06M: Explanation: IPL from 6 GeV / 521224170M
- 4A-01M: Explanation: IPL from 6 GeV / 534213075,534213105,534213135,53427000M,5348065M
- 4A-10M: Explanation: IPL from 6 GeV 5212111100M, / 521221215, 532111090M, 532112050M, 534213045 and 5362580M

| ID | WBS | Activity | Type | Duration | Start | Finish | Predecessors | Total float | Constraint | Resources | Cost | RESP - Responsibility | Special | STRT%COMP for CM EVM | FNSH%COMP for CM EVM | WBS ASSIGNMENT | CAM RESPONSIBLE | CR 09-012 | Planned FinishUDF | CR 13-014 | ReBaseline Actuals Adjustment | Milestone Level |
| --- | --- | --- | --- | --- | --- | --- | --- | --- | --- | --- | --- | --- | --- | --- | --- | --- | --- | --- | --- | --- | --- | --- |
|  | 0 | **1.0 CONCEPTUAL & ADVANCED CONCEPTUAL DESIGN REVIEW ACTIVITIES** |  |  | 2006-10-02 | 2013-08-30 |  |  |  |  |  |  |  |  |  |  |  |  |  |  |  |  |
| 19001 |  | FY06 Obligations RKC (Oct-Dec 06) |  | 58d | 2006-10-02 | 2006-12-22 | 9-070M | 0d | finish on 2006-12-22 | PROCUREMENT<$50K 60; PLABOR | 6,839 | PARKINSON J | LR | 1 | 1 | 1.0 | CLAUS R | 09-012 |  |  |  |  |
| 19002RKC |  | FY06 Obligations Exp over $50k RKC (Oct-Dec 06) |  | 58d | 2006-10-02 | 2006-12-22 | 9-070M | 0d | finish on 2006-12-22 | EXPENSES >$50 69 | -2,716 | PARKINSON J | LR | 1 | 1 | 1.0 | CLAUS R |  |  |  |  |  |
| 19001RKC |  | FY06 Obligations RKC (Jan-Sep 06) |  | 189d | 2007-01-02 | 2007-09-28 | 19001 | 0d | mandatory start 2007-01-02 | PLABOR; SUPPLIES & MATERIALS; PROCUREMENT<$50K 60 | 341,960 | PARKINSON J | LR | 1 | 1 | 1.0 | CLAUS R | 09-012 |  |  |  |  |
| 19005RKC |  | FY06 Obligations Exp over $50k RKC (Jan-Sep 06) |  | 189d | 2007-01-02 | 2007-09-28 | 19002RKC | 0d | mandatory start 2007-01-02 | EXPENSES >$50 69 | 136,228 | PARKINSON J | LR | 1 | 1 | 1.0 | CLAUS R |  | 2007-09-28 |  |  |  |
| 19010 |  | Re-Baseline Actuals Adjustment |  | 1d | 2013-08-30 | 2013-08-30 | 9-130M FS+227d | 20d |  | PROCUREMENT>$50K 69 NO ESCALATION | -32,159.42 | PARKINSON J |  | 1 | 1 |  | CLAUS R |  |  | 13-014 | ADJ |  |
|  | 1 | **1.0.1 ACCELERATOR SYSTEMS** |  |  |  |  |  |  |  |  |  |  |  |  |  |  |  |  |  |  |  |  |
|  | 1 | **1.0.1.1 CRYOMODULES** |  |  |  |  |  |  |  |  |  |  |  |  |  |  |  |  |  |  |  |  |
|  | 2 | **1.0.1.2 POWER SYSTEMS** |  |  |  |  |  |  |  |  |  |  |  |  |  |  |  |  |  |  |  |  |
|  | 3 | **1.0.1.3 CRYOGENICS** |  |  |  |  |  |  |  |  |  |  |  |  |  |  |  |  |  |  |  |  |
|  | 4 | **1.0.1.4 BEAM TRANSPORT** |  |  |  |  |  |  |  |  |  |  |  |  |  |  |  |  |  |  |  |  |
|  | 5 | **1.0.1.5 EXTRACTION** |  |  |  |  |  |  |  |  |  |  |  |  |  |  |  |  |  |  |  |  |
|  | 6 | **1.0.1.6 INSTRUMENTATION, CONTROLS, & SAFETY SYSTEMS** |  |  |  |  |  |  |  |  |  |  |  |  |  |  |  |  |  |  |  |  |
|  | 2 | **1.0.2 HALLS A. B, & C** |  |  |  |  |  |  |  |  |  |  |  |  |  |  |  |  |  |  |  |  |
|  | 1 | **1.0.2.1 HALL A** |  |  |  |  |  |  |  |  |  |  |  |  |  |  |  |  |  |  |  |  |
|  | 2 | **1.0.2.2 HALL B** |  |  |  |  |  |  |  |  |  |  |  |  |  |  |  |  |  |  |  |  |
|  | 3 | **1.0.2.3 HALL C** |  |  |  |  |  |  |  |  |  |  |  |  |  |  |  |  |  |  |  |  |
|  | 3 | **1.0.3 HALL D** |  |  |  |  |  |  |  |  |  |  |  |  |  |  |  |  |  |  |  |  |
|  | 4 | **1.0.4 CIVIL** |  |  |  |  |  |  |  |  |  |  |  |  |  |  |  |  |  |  |  |  |
|  | 1 | **1.1 R&D** |  |  | 2006-10-02 | 2013-08-30 |  |  |  |  |  |  |  |  |  |  |  |  |  |  |  |  |
|  | 1 | **1.1.1 ACCELERATOR SYSTEMS** |  |  | 2006-10-02 | 2013-08-30 |  |  |  |  |  |  |  |  |  |  |  |  |  |  |  |  |
|  | 1 | **1.1.1.1 CRYOMODULES** |  |  | 2006-10-02 | 2013-08-30 |  |  |  |  |  |  |  |  |  |  |  |  |  |  |  |  |
|  | 1 | **1.1.1.1.1 FY06/07 R&D Plan** |  |  | 2006-10-02 | 2007-04-11 |  |  |  |  |  |  |  |  |  |  |  |  |  |  |  |  |
| 11111005RKC |  | FY06 Obligations RKC |  | 120d | 2006-10-02 | 2007-03-30 | 9-070M | 333d |  | PLABOR; SUPPLIES & MATERIALS | 56,267.74 | HOGAN J | LR | 1 | 1 | 1.1.1.1 | JOHN H |  | 2007-03-30 |  |  |  |
| 11111000M |  | 12 GeV R&D & CDs (Finish 1 Month Later) (R&D PLAN) | milestone | 0d | 2007-04-11 | 2007-04-11 | 111123015 | 56d |  |  |  | HOGAN J |  | 1 | 1 | 1.1.1.1 | JOHN H |  | 2007-03-15 |  |  | 6 |

Notes:
- 19001: Current Status: Added FY06 Obligations used Travel / for EDP and combined Purch/Serv/Labor/Consult into one number.
- 19002RKC: Current Status: Added FY06 Obligations used Travel / for EDP and combined Purch/Serv/Labor/Consult into one number.
- 19001RKC: Current Status: Added FY06 Obligations used Travel / for EDP and combined Purch/Serv/Labor/Consult into one number.
- 19005RKC: Current Status: Added FY06 Obligations used Travel / for EDP and combined Purch/Serv/Labor/Consult into one number.

| ID | WBS | Activity | Type | Duration | Start | Finish | Predecessors | Total float | Free float | Constraint | Resources | Cost | Planned FinishUDF | RESP - Responsibility | STRT%COMP for CM EVM | FNSH%COMP for CM EVM | WBS ASSIGNMENT | CAM RESPONSIBLE | CR 09-012 | Milestone Level | CR 13-014 | ReBaseline Actuals Adjustment | Risk Item Number | CR 07-009 | CR 08-025 |
| --- | --- | --- | --- | --- | --- | --- | --- | --- | --- | --- | --- | --- | --- | --- | --- | --- | --- | --- | --- | --- | --- | --- | --- | --- | --- |
|  | 1 | **1.1.1.1.1.1 R1 Testing in FEL** |  |  |  |  |  |  |  |  |  |  |  |  |  |  |  |  |  |  |  |  |  |  |  |
|  | 2 | **1.1.1.1.1.2 RF Window** |  |  |  |  |  |  |  |  |  |  |  |  |  |  |  |  |  |  |  |  |  |  |  |
|  | 3 | **1.1.1.1.1.3 Cavity Processing** |  |  |  |  |  |  |  |  |  |  |  |  |  |  |  |  |  |  |  |  |  |  |  |
|  | 4 | **1.1.1.1.1.4 Tuner** |  |  |  |  |  |  |  |  |  |  |  |  |  |  |  |  |  |  |  |  |  |  |  |
|  | 2 | **1.1.1.1.2 Post R1 Plan** |  |  | 2006-10-02 | 2013-08-30 |  |  |  |  |  |  |  |  |  |  |  |  |  |  |  |  |  |  |  |
|  | 1 | **1.1.1.1.2.1 Cavity** |  |  | 2006-10-02 | 2013-08-30 |  |  |  |  |  |  |  |  |  |  |  |  |  |  |  |  |  |  |  |
| 111121000 |  | Fab. C100 Niobium Cavities x 2 (CAVITY) |  | 11d | 2006-10-02 | 2006-10-16 | 9-070M | 34d | 0d |  | MSHOP; MECH TECH [30.8 h]; ELEC TECH [22 h]; MECH DES [13.2 h]; MECH ENG [8.8 h]; MECH ENG [22 h]; MECH ENG [7.04 h]; MECH ENG [17.6 h] | 8,840.46 | 2006-10-16 | HOGAN J | 1 | 1 | 1.1.1.1 | JOHN H | 09-012 |  |  |  |  |  |  |
| 111121005M |  | Cavity Fabrication Complete (Finish 9/29/06) (CAVITY) | milestone | 0d | 2006-10-16 | 2006-10-16 | 111121000 | 34d | 0d |  |  |  | 2006-10-16 | HOGAN J | 1 | 1 | 1.1.1.1 | JOHN H |  | 6 |  |  |  |  |  |
| 111121010 |  | Re-Baseline Actuals Adjustment |  | 1d | 2013-08-30 | 2013-08-30 | 9-130M FS+227d | 20d |  |  | PROCUREMENT>$50K 69 NO ESCALATION | 69,321.11 |  | HOGAN J | 1 | 1 |  | JOHN H |  |  | 13-014 | ADJ |  |  |  |
|  | 2 | **1.1.1.1.2.2 Power Coupler** |  |  | 2006-10-02 | 2007-01-02 |  |  |  |  |  |  |  |  |  |  |  |  |  |  |  |  |  |  |  |
| 111122000 |  | Fabricate FPC for HTB Testing (PWR CPLR) |  | 59d | 2006-10-02 | 2007-01-02 | 9-070M | 13d | 0d |  | ELEC TECH [80 h]; PROCUREMENT<$50K 60; MECH ENG [40 h]; PROCUREMENT>$50K 69; MECH DES [80 h]; MECH ENG [80 h] | 84,851.6 | 2007-01-02 | HOGAN J | 1 | 1 | 1.1.1.1 | JOHN H |  |  |  |  |  |  |  |
| 111122005M |  | Power Coupler Prototype Fab Complete (PWR CPLR) | milestone | 0d | 2007-01-02 | 2007-01-02 | 111122000 | 13d | 0d |  |  |  | 2007-01-02 | HOGAN J | 1 | 1 | 1.1.1.1 | JOHN H |  | 6 |  |  |  |  |  |
|  | 3 | **1.1.1.1.2.3 Evaluation** |  |  | 2006-10-17 | 2007-04-11 |  |  |  |  |  |  |  |  |  |  |  |  |  |  |  |  |  |  |  |
| 111123000 |  | Conduct VTA Test C100 Cavities (EVALUATION) |  | 47d | 2006-10-17 | 2006-12-22 | 111121005M, 111121000 | 34d | 21d |  | MECH TECH [40 h]; ELEC TECH [80 h]; MECH TECH [160 h]; ELEC ENG [40 h]; MECH ENG [80 h]; MECH ENG [160 h]; PROCUREMENT<$50K 60; MECH TECH [32 h]; SCIENTIST [16 h] | 47,262.4 | 2006-12-22 | HOGAN J | 1 | 1 | 1.1.1.1 | JOHN H |  |  |  |  |  |  |  |
| 111123005 |  | Conduct Integrated Test in HTB (EVALUATION) |  | 30d | 2007-02-01 | 2007-03-15 | 111122005M FS+20d, 111124000, 111123000 | 13d | 0d |  | MECH ENG [40 h]; MECH TECH [40 h]; MECH DES [40 h]; ELEC ENG [200 h]; MECH ENG [120 h]; PROCUREMENT<$50K 60 | 48,895.6 | 2007-03-15 | HOGAN J | 1 | 1 | 1.1.1.1 | JOHN H |  |  |  |  |  |  |  |
| 111123010M |  | Integrated Testing Complete (EVALUATION) | milestone | 0d | 2007-03-15 | 2007-03-15 | 111123005 | 13d | 0d |  |  |  | 2007-03-15 | HOGAN J | 1 | 1 | 1.1.1.1 | JOHN H |  | 6 |  |  |  |  |  |
| 111123015 |  | 1/4 Cryomodule CR Accounting Change Request (Finish by 4/30/07) |  | 19d | 2007-03-16 | 2007-04-11 | 111123010M | 13d | 0d | finish on or before 2007-04-30 | MECH ENG [891.1 h]; MSHOP; SR STAFF [178 h]; PROCUREMENT<$50K 60; PROCUREMENT>$50K 69; MECH DES [175.2 h]; ELEC TECH [32.4 h]; ELEC ENG [-162.51 h]; SCIENTIST [-8.8 h]; MECH TECH [1152.53 h]; SUPPLIES & MATERIALS | 195,226.58 | 2007-01-24 | HOGAN J | 1 | 1 | 1.1.1.1 | JOHN H | 09-012 |  |  |  | 2,3,4 | 07-009 |  |
|  | 4 | **1.1.1.1.2.4 Tuner** |  |  | 2006-10-17 | 2006-12-15 |  |  |  |  |  |  |  |  |  |  |  |  |  |  |  |  |  |  |  |
| 111124000 |  | Procure Prototype Components (TUNER) |  | 42d | 2006-10-17 | 2006-12-15 | 111121000 | 39d | 26d |  | MECH ENG [8 h]; PROCUREMENT>$50K 69; MECH ENG [16 h]; PROCUREMENT<$50K 60; MECH DES [32 h] | 55,488.96 | 2006-12-15 | HOGAN J | 1 | 1 | 1.1.1.1 | JOHN H |  |  |  |  |  |  |  |
|  | 3 | **1.1.1.1.3 Critical Decisions** |  |  |  |  |  |  |  |  |  |  |  |  |  |  |  |  |  |  |  |  |  |  |  |
|  | 1 | **1.1.1.1.3.1 CD2A** |  |  |  |  |  |  |  |  |  |  |  |  |  |  |  |  |  |  |  |  |  |  |  |
|  | 2 | **1.1.1.1.3.2 CD2B** |  |  |  |  |  |  |  |  |  |  |  |  |  |  |  |  |  |  |  |  |  |  |  |
|  | 3 | **1.1.1.1.3.3 CD3A** |  |  |  |  |  |  |  |  |  |  |  |  |  |  |  |  |  |  |  |  |  |  |  |
|  | 4 | **1.1.1.1.3.4 CD3B** |  |  |  |  |  |  |  |  |  |  |  |  |  |  |  |  |  |  |  |  |  |  |  |
|  | 5 | **1.1.1.1.3.5 CD4** |  |  |  |  |  |  |  |  |  |  |  |  |  |  |  |  |  |  |  |  |  |  |  |
|  | 4 | **1.1.1.1.4 HOM MEASUREMENTS** |  |  | 2008-03-13 | 2008-07-11 |  |  |  |  |  |  |  |  |  |  |  |  |  |  |  |  |  |  |  |
| 11114000 |  | Prepare for HTB test |  | 16d | 2008-03-13 | 2008-04-03 | 9-080M FS+107d | 56.5d | 0d |  | SUPPLIES & MATERIALS; MECH ENG [240 h]; MECH DES [60 h] | 24,390.4 |  | HOGAN J | 1 | 1 |  | JOHN H |  |  |  |  |  |  | 08-025 |
| 11114005 |  | Procure/fabricate/modify HOM hardware |  | 13.5d | 2008-03-24 | 2008-04-10 | 11114000 FS-9d | 56.5d | 0d |  | MECH TECH [180 h] | 7,056 |  | HOGAN J | 1 | 1 |  | JOHN H |  |  |  |  |  |  | 08-025 |
| 11114010 |  | Assemble HTB |  | 6d | 2008-04-10 | 2008-04-18 | 11114005 | 56.5d | 0d |  | MECH TECH [60 h]; MECH ENG [72 h] | 6,804.48 |  | HOGAN J | 1 | 1 |  | JOHN H | 09-012 |  |  |  |  |  | 08-025 |
| 11114015M |  | HTB Assembly Completed | milestone | 0d | 2008-04-18 | 2008-04-18 | 11114010 | 56.5d | 0d |  |  |  |  | HOGAN J | 1 | 1 |  | JOHN H |  |  |  |  |  |  | 08-025 |
| 11114020 |  | Install into CMTF/Cooldown |  | 5d | 2008-04-18 | 2008-04-25 | 11114015M | 56.5d | 0d |  | MECH ENG [80 h] | 4,947.2 |  | HOGAN J | 1 | 1 |  | JOHN H | 09-012 |  |  |  |  |  | 08-025 |
| 11114025 |  | Perform HOM measurements in HTB |  | 5d | 2008-04-25 | 2008-05-02 | 11114020 | 56.5d | 0d |  | SR STAFF [80 h] | 7,972.8 |  | HOGAN J | 1 | 1 |  | JOHN H |  |  |  |  |  |  | 08-025 |
| 11114030M |  | Q's measured and analyzed Completed | milestone | 0d | 2008-05-02 | 2008-05-02 | 11114025 | 56.5d | 0d |  |  |  |  | HOGAN J | 1 | 1 |  | JOHN H |  |  |  |  |  |  | 08-025 |
| 11114035 |  | Perform thermal measurements |  | 5d | 2008-05-02 | 2008-05-09 | 11114030M | 56.5d | 0d |  | SCIENTIST [80 h] | 4,981.6 |  | HOGAN J | 1 | 1 |  | JOHN H |  |  |  |  |  |  | 08-025 |
| 11114045 |  | Data Analysis |  | 14d | 2008-05-09 | 2008-05-30 | 11114035 | 56.5d | 0d |  | SR STAFF [156 h] | 15,546.96 |  | HOGAN J | 1 | 1 |  | JOHN H |  |  |  |  |  |  | 08-025 |
| 11114050M |  | Interim report Completed | milestone | 0d | 2008-05-09 | 2008-05-09 | 11114035 | 80.5d | 24d |  |  |  |  | HOGAN J | 1 | 1 |  | JOHN H |  |  |  |  |  |  | 08-025 |
| 11114040 |  | WarmUp & Disassemble |  | 10d | 2008-05-30 | 2008-06-13 | 11114045 | 56.5d | 0d |  | MECH ENG [120 h]; MECH TECH [120 h] | 12,124.8 |  | HOGAN J | 1 | 1 |  | JOHN H |  |  |  |  |  |  | 08-025 |
| 11114055 |  | VTA tests: prep and execution |  | 14.5d | 2008-06-13 | 2008-07-03 | 11114050M, 11114040 | 56.5d | 0d |  | ELEC ENG [80 h]; MECH ENG [80 h]; MECH TECH [160 h] | 16,198.4 |  | HOGAN J | 1 | 1 |  | JOHN H |  |  |  |  |  |  | 08-025 |
| 11114060 |  | Disassemble and store components |  | 4.5d | 2008-07-07 | 2008-07-11 | 11114055 | 56.5d | 0d |  | MECH TECH [80 h] | 3,136 |  | HOGAN J | 1 | 1 |  | JOHN H |  |  |  |  |  |  | 08-025 |
| 11114065 |  | Data Analysis |  | 4.5d | 2008-07-07 | 2008-07-11 | 11114055 | 56.5d | 0d |  | SR STAFF [80 h] | 7,972.8 |  | HOGAN J | 1 | 1 |  | JOHN H |  |  |  |  |  |  | 08-025 |
| 11114070M |  | Final Report and All Tasks Completed | milestone | 0d | 2008-07-11 | 2008-07-11 | 11114060, 11114065 | 56.5d | 0d |  |  |  |  | HOGAN J | 1 | 1 |  | JOHN H |  |  |  |  |  |  | 08-025 |

| ID | WBS | Activity | Type | Duration | Start | Finish | Predecessors | Total float | Free float | Resources | Cost | RESP - Responsibility | STRT%COMP for CM EVM | FNSH%COMP for CM EVM | CR 08-025 | CAM RESPONSIBLE | CR 08-054 | CR 10-027 | CR 10-064 | CR 11-051 | CR 12-018 | Planned FinishUDF | WBS ASSIGNMENT | Milestone Level | CR 13-014 | ReBaseline Actuals Adjustment | CR 08-004 | CR 07-019 |
| --- | --- | --- | --- | --- | --- | --- | --- | --- | --- | --- | --- | --- | --- | --- | --- | --- | --- | --- | --- | --- | --- | --- | --- | --- | --- | --- | --- | --- |
|  | 5 | **1.1.1.1.5 WAVEGUIDE FUNDAMENTAL POWER COUPLER TESTS** |  |  | 2008-06-02 | 2008-12-18 |  |  |  |  |  |  |  |  |  |  |  |  |  |  |  |  |  |  |  |  |  |  |
| 11115000 |  | Developement of Documentation & Detail Plans |  | 20d | 2008-06-02 | 2008-06-27 | 9-080M FS+163d | 368d | 0d | MECH ENG [80 h]; MECH TECH [200 h]; SUPPLIES & MATERIALS; COMP SCIENT [40 h]; SCIENTIST [40 h] | 18,592.8 | HOGAN J | 1 | 1 | 08-025 | JOHN H | 08-054 | 10-027 | 10-064 | 11-051 | 12-018F |  |  |  |  |  |  |  |
| 11115005 |  | Vendor Fab 15 Waveguide Fundamental Power Couplers |  | 120d | 2008-06-30 | 2008-12-18 | 11115000 | 368d | 5d | PROCUREMENT>$50K 69 NO ESCALATION FY09; PROCUREMENT<$50K 60 NO ESCALATION FY09 | 79,305 | HOGAN J | 1 | 1 | 08-025 | JOHN H | 08-054 | 10-027 | 10-064 | 11-051 | 12-018F |  |  |  |  |  |  |  |
|  | 2 | **1.1.1.2 POWER SYSTEMS** |  |  | 2007-03-15 | 2013-08-30 |  |  |  |  |  |  |  |  |  |  |  |  |  |  |  |  |  |  |  |  |  |  |
| 1112000 |  | Conduct Interlock Check Out (POWER SYSTEMS) |  | 10d | 2007-03-15 | 2007-03-28 | 9-070M FS+108d | 269d | 0d | ELEC TECH [40 h]; ELEC ENG [40 h] | 4,299.6 | HOVATER C | 1 | 1 |  | BILL M |  |  |  |  |  | 2007-03-28 | 1.1.1.2 |  |  |  |  |  |
| 1112005 |  | Conduct RF - Cavity System Tests (POWER SYSTEMS) |  | 44d | 2007-04-16 | 2007-06-15 | 1112000 FS+12d | 269d | 0d | SCIENTIST [80 h]; ELEC TECH [80 h]; ELEC ENG [320 h]; COMP SCIENT [80 h] | 32,750.4 | HOVATER C | 1 | 1 |  | BILL M |  |  |  |  |  | 2007-06-15 | 1.1.1.2 |  |  |  |  |  |
| 1112010 |  | Report Writing (POWER SYSTEMS) |  | 13d | 2007-05-30 | 2007-06-15 | 1112005 FS-13d | 269d | 0d | ELEC ENG [40 h] | 2,484.8 | HOVATER C | 1 | 1 |  | BILL M |  |  |  |  |  | 2007-06-15 | 1.1.1.2 |  |  |  |  |  |
| 1112015M |  | Report sent to DOE (POWER SYSTEMS) | milestone | 0d | 2007-06-29 | 2007-06-29 | 1112010 FS+10d | 269d |  |  |  | HOVATER C | 1 | 1 |  | BILL M |  |  |  |  |  | 2007-06-29 | 1.1.1.2 | 6 |  |  |  |  |
| 1112020 |  | Re-Baseline Actuals Adjustment |  | 1d | 2013-08-30 | 2013-08-30 | 9-130M FS+227d | 20d |  | PROCUREMENT>$50K 69 NO ESCALATION | -11,919.46 | HOVATER C | 1 | 1 |  | BILL M |  |  |  |  |  |  |  |  | 13-014 | ADJ |  |  |
|  | 3 | **1.1.1.3 CRYOGENICS** |  |  |  |  |  |  |  |  |  |  |  |  |  |  |  |  |  |  |  |  |  |  |  |  |  |  |
|  | 4 | **1.1.1.4 BEAM TRANSPORT** |  |  | 2007-11-01 | 2013-08-30 |  |  |  |  |  |  |  |  |  |  |  |  |  |  |  |  |  |  |  |  |  |  |
| 1114000 |  | Fabricate QP and QR Laminations |  | 62d | 2007-11-01 | 2008-02-08 | 9-080M FS+23d | 78d | 0d | PROCUREMENT<$50K 60 | 28,480.44 | BEVINS M | 1 | 1 |  | MIKE B |  |  |  |  |  |  | 1.1.1.4 |  |  |  | 08-004 |  |
| 1114005 |  | Fabricate Coils and Assemble magnets |  | 81d | 2007-12-03 | 2008-04-04 | 1114000 FS-42d | 78d | 0d | MECH ENG [60 h]; MECH TECH [480 h]; PROCUREMENT<$50K 60 | 28,201.85 | BEVINS M | 1 | 1 |  | MIKE B |  |  |  |  |  |  | 1.1.1.4 |  |  |  | 08-004 |  |
| 1114010 |  | Test and measure QP and QR |  | 60d | 2008-03-18 | 2008-06-10 | 1114005 FS-14d | 78d |  | MECH ENG [80 h]; MECH TECH [172 h]; PROCUREMENT<$50K 60 | 16,333.15 | BEVINS M | 1 | 1 |  | MIKE B |  |  |  |  |  |  | 1.1.1.4 |  |  |  | 08-004 |  |
| 1114015 |  | Re-Baseline Actuals Adjustment |  | 1d | 2013-08-30 | 2013-08-30 | 9-130M FS+227d | 20d |  | PROCUREMENT>$50K 69 NO ESCALATION | 45,652.72 | BEVINS M | 1 | 1 |  | MIKE B |  |  |  |  |  |  |  |  | 13-014 | ADJ |  |  |
|  | 5 | **1.1.1.5 EXTRACTION** |  |  |  |  |  |  |  |  |  |  |  |  |  |  |  |  |  |  |  |  |  |  |  |  |  |  |
|  | 6 | **1.1.1.6 INSTRUMENTATION, CONTROLS, & SAFETY SYSTEMS** |  |  |  |  |  |  |  |  |  |  |  |  |  |  |  |  |  |  |  |  |  |  |  |  |  |  |
|  | 2 | **1.1.2 HALL A** |  |  | 2013-08-30 | 2013-08-30 |  |  |  |  |  |  |  |  |  |  |  |  |  |  |  |  |  |  |  |  |  |  |
|  | 1 | **1.1.2.1 MAGNET** |  |  | 2013-08-30 | 2013-08-30 |  |  |  |  |  |  |  |  |  |  |  |  |  |  |  |  |  |  |  |  |  |  |
| 1121000 |  | Re-Baseline Actuals Adjustment |  | 1d | 2013-08-30 | 2013-08-30 | 9-130M FS+227d | 20d |  | PROCUREMENT>$50K 69 NO ESCALATION |  | ELOUADRHIRI L | 1 | 1 |  | LATIFA E |  |  |  |  |  |  |  |  | 13-014 | ADJ |  |  |
|  | 2 | **1.1.2.2 DETECTOR** |  |  |  |  |  |  |  |  |  |  |  |  |  |  |  |  |  |  |  |  |  |  |  |  |  |  |
|  | 3 | **1.1.2.3 COMPUTING** |  |  |  |  |  |  |  |  |  |  |  |  |  |  |  |  |  |  |  |  |  |  |  |  |  |  |
|  | 4 | **1.1.2.4 ELECTRONICS** |  |  |  |  |  |  |  |  |  |  |  |  |  |  |  |  |  |  |  |  |  |  |  |  |  |  |
|  | 5 | **1.1.2.5 BEAMLINE** |  |  |  |  |  |  |  |  |  |  |  |  |  |  |  |  |  |  |  |  |  |  |  |  |  |  |
|  | 6 | **1.1.2.6 INFRASTRUCTURE** |  |  |  |  |  |  |  |  |  |  |  |  |  |  |  |  |  |  |  |  |  |  |  |  |  |  |
|  | 3 | **1.1.3 HALL B** |  |  | 2006-10-02 | 2013-08-30 |  |  |  |  |  |  |  |  |  |  |  |  |  |  |  |  |  |  |  |  |  |  |
|  | 1 | **1.1.3.1 TORUS MAGNET R&D** |  |  | 2007-06-18 | 2013-08-30 |  |  |  |  |  |  |  |  |  |  |  |  |  |  |  |  |  |  |  |  |  |  |
| 1131005 |  | Conduct SC Magnet Cable Testing |  | 20d | 2007-06-18 | 2007-07-16 | 9-070M FS+174d | 162d | 35d | PROCUREMENT<$50K 60 | 43,000 | ELOUADRHIRI L | 1 | 1 |  | LATIFA E |  |  |  |  |  |  | 1.1.3.1 |  |  |  |  | 07-019 |
| 1131010 |  | Re-Baseline Actuals Adjustment |  | 1d | 2013-08-30 | 2013-08-30 | 9-130M FS+227d | 20d |  | PROCUREMENT>$50K 69 NO ESCALATION | -3,000 | ELOUADRHIRI L | 1 | 1 |  | LATIFA E |  |  |  |  |  |  |  |  | 13-014 | ADJ |  |  |

| ID | WBS | Activity | Type | Duration | Start | Finish | Predecessors | Total float | Free float | Resources | Cost | Planned FinishUDF | RESP - Responsibility | Special | STRT%COMP for CM EVM | FNSH%COMP for CM EVM | WBS ASSIGNMENT | CAM RESPONSIBLE | Milestone Level | CR 09-012 | HALL DUR EST | CR 07-027 | CR 08-021 | CR 08-022 | CR 13-014 | ReBaseline Actuals Adjustment |
| --- | --- | --- | --- | --- | --- | --- | --- | --- | --- | --- | --- | --- | --- | --- | --- | --- | --- | --- | --- | --- | --- | --- | --- | --- | --- | --- |
|  | 2 | **1.1.3.2 DETECTOR R&D** |  |  | 2006-10-02 | 2013-08-30 |  |  |  |  |  |  |  |  |  |  |  |  |  |  |  |  |  |  |  |  |
| 1132021RKC |  | FY06 Obligations RKC |  | 120d | 2006-10-02 | 2007-03-30 | 9-070M | 333d |  | SUPPLIES & MATERIALS | 24,045.6 | 2007-03-30 | PARKINSON J | LR | 1 | 1 | 1.1.3.2 | LATIFA E |  |  |  |  |  |  |  |  |
| 1132026M |  | FY07-HTCC -R&D Plans & Initial Safety Assessment (DTCTR R&D) | milestone | 0d | 2006-10-02 | 2006-10-02 | 9-070M | 1d | 0d |  |  | 2006-10-02 | ELOUADRHIRI L |  | 1 | 1 | 1.1.3.2 | LATIFA E | 6 |  |  |  |  |  |  |  |
| 1132028 |  | FY07-HTCC - Testing of the prototype (DTCTR R&D) |  | 61d | 2006-10-02 | 2007-01-04 | 1132026M | 1d | 0d | SCIENTIST [34.4 h]; PD UNIV STUDNT [217.6 h]; CONTRB UNIV LBR [121 h] | 4,373.26 | 2007-01-04 | ELOUADRHIRI L |  | 1 | 1 | 1.1.3.2 | LATIFA E |  |  |  |  |  |  |  |  |
| 1132033M |  | FY07-EC -R&D Plans & Initial Safety Assessment (DTCTR R&D) | milestone | 0d | 2006-10-02 | 2006-10-02 | 9-070M | 1d | 0d |  |  | 2006-10-02 | ELOUADRHIRI L |  | 1 | 1 | 1.1.3.2 | LATIFA E | 6 |  |  |  |  |  |  |  |
| 1132035 |  | FY07-EC - Fullscale prototype design (DTCTR R&D) |  | 79d | 2006-10-02 | 2007-01-31 | 1132033M | 1d | 0d | SCIENTIST [22 h]; CONTRB UNIV LBR [109.01 h]; PD UNIV STUDNT [200 h] | 3,402.18 | 2007-01-31 | ELOUADRHIRI L |  | 1 | 1 | 1.1.3.2 | LATIFA E |  |  |  |  |  |  |  |  |
| 1132054M |  | FY07-DC Plans & Initial Safety Assessment (DTCTR R&D) | milestone | 0d | 2006-10-02 | 2006-10-02 | 9-070M | 1d | 0d |  |  | 2006-10-02 | ELOUADRHIRI L |  | 1 | 1 | 1.1.3.2 | LATIFA E | 6 |  |  |  |  |  |  |  |
| 1132055 |  | FY07-DC - Mechanical protoptyping (DTCTR R&D) |  | 125d | 2006-10-02 | 2007-04-06 | 1132054M | 1d | 0d | CONTRB UNIV LBR [479.62 h]; MECH TECH [479.62 h]; MECH DES [218.01 h]; MECH ENG [22 h]; PROCUREMENT<$50K 60 | 58,312.51 | 2007-04-06 | ELOUADRHIRI L |  | 1 | 1 | 1.1.3.2 | LATIFA E |  |  |  |  |  |  |  |  |
| 1132060 |  | FY07-DC - Electrical prototyping (DTCTR R&D) |  | 125d | 2006-10-02 | 2007-04-06 | 9-070M | 1d | 0d | ELEC ENG [21.8 h]; PROCUREMENT<$50K 60; ELEC DES [239.81 h]; ELEC TECH [109.01 h] | 33,653.15 | 2007-04-06 | ELOUADRHIRI L |  | 1 | 1 | 1.1.3.2 | LATIFA E |  |  |  |  |  |  |  |  |
| 1132069M |  | FY07-FTOF -R&D Plans & Initial Safety Assessment (DTCTR R&D) | milestone | 0d | 2006-10-02 | 2006-10-02 | 9-070M | 1d | 0d |  |  | 2006-10-02 | ELOUADRHIRI L |  | 1 | 1 | 1.1.3.2 | LATIFA E | 6 |  |  |  |  |  |  |  |
| 1132070 |  | FY07-FTOF - Building the prototype (DTCTR R&D) |  | 98d | 2006-10-02 | 2007-02-28 | 1132069M | 1d | 0d | PROCUREMENT<$50K 60 | 16,926 | 2007-02-28 | ELOUADRHIRI L |  | 1 | 1 | 1.1.3.2 | LATIFA E |  | 09-012 |  |  |  |  |  |  |
| 1132079M |  | FY07-CTOF -R&D Plans & Initial Safety Assessment (DTCTR R&D) | milestone | 0d | 2006-10-02 | 2006-10-02 | 9-070M | 1d | 0d |  |  | 2006-10-02 | ELOUADRHIRI L |  | 1 | 1 | 1.1.3.2 | LATIFA E | 6 |  |  |  |  |  |  |  |
| 1132080 |  | FY07-CTOF - Design of the prototype (DTCTR R&D) |  | 55d | 2006-10-02 | 2006-12-19 | 1132079M | 1d | 0d |  |  | 2006-12-19 | ELOUADRHIRI L |  | 1 | 1 | 1.1.3.2 | LATIFA E |  | 09-012 |  |  |  |  |  |  |
| 1132094M |  | FY07-SVT -R&D Plans & Initial Safety Assessment (DTCTR R&D) | milestone | 0d | 2006-10-02 | 2006-10-02 | 9-070M | 1d | 0d |  |  | 2006-10-02 | ELOUADRHIRI L |  | 1 | 1 | 1.1.3.2 | LATIFA E | 6 |  |  |  |  |  |  |  |
| 1132095 |  | FY07-SVT - prototyping (DTCTR R&D) |  | 125d | 2006-10-02 | 2007-04-06 | 1132094M | 1d | 0d | CONTRB UNIV LBR [479.62 h]; ELEC ENG [545.03 h]; SCIENTIST [43.6 h]; PROCUREMENT<$50K 60 | 64,111.46 | 2007-04-06 | ELOUADRHIRI L |  | 1 | 1 | 1.1.3.2 | LATIFA E |  |  |  |  |  |  |  |  |
| 1132085 |  | FY07-CTOF - Building the prototype (DTCTR R&D) |  | 67d | 2006-12-20 | 2007-04-03 | 1132080 | 1d | 0d |  |  | 2007-04-03 | ELOUADRHIRI L |  | 1 | 1 | 1.1.3.2 | LATIFA E |  | 09-012 |  |  |  |  |  |  |
| 1132030 |  | FY07-HTCC - Analysis of the prototype (DTCTR R&D) |  | 186d | 2007-01-05 | 2007-09-28 | 1132028 | 1d | 0d | CONTRB UNIV LBR [108.8 h]; PD UNIV STUDNT [192.4 h]; SCIENTIST [22 h] | 3,226.23 | 2007-09-28 | ELOUADRHIRI L |  | 1 | 1 | 1.1.3.2 | LATIFA E |  |  |  |  |  |  |  |  |
| 1132045 |  | FY07-EC - Manufacturing the box and fixtures for the full scale protoptye (DTCTR R&D) |  | 65d | 2007-02-01 | 2007-05-03 | 1132035 | 1d | 0d | MECH DES [43.6 h]; MECH TECH [387.6 h]; PROCUREMENT<$50K 60; MECH ENG [22 h] | 46,957.3 | 2007-05-03 | ELOUADRHIRI L |  | 1 | 1 | 1.1.3.2 | LATIFA E |  |  |  |  |  |  |  |  |
| 1132075 |  | FY07-FTOF - Testing and data analysis from the prototype (DTCTR R&D) |  | 149d | 2007-03-01 | 2007-09-28 | 1132070 | 1d | 0d | PROCUREMENT<$50K 60 | 11,284 | 2007-09-28 | ELOUADRHIRI L |  | 1 | 1 | 1.1.3.2 | LATIFA E |  | 09-012 |  |  |  |  |  |  |
| 1132090 |  | FY07-CTOF - Testing of the prototype (DTCTR R&D) |  | 125d | 2007-04-04 | 2007-09-28 | 1132085, 1132080 | 1d | 0d | TRAVEL | 15,890 | 2007-09-28 | ELOUADRHIRI L |  | 1 | 1 | 1.1.3.2 | LATIFA E |  | 09-012 |  |  |  |  |  |  |
| 1132065 |  | FY07-DC - Testing & analysis of the prototype (DTCTR R&D) |  | 122d | 2007-04-09 | 2007-09-28 | 1132055, 1132060 | 1d | 0d | ELEC TECH [108.8 h]; ELEC DES [239.6 h]; ELEC ENG [21.6 h] | 16,060.61 | 2007-09-28 | ELOUADRHIRI L |  | 1 | 1 | 1.1.3.2 | LATIFA E |  |  |  |  |  |  |  |  |
| 1132100 |  | FY07-SVT - testing of the prototype (DTCTR R&D) |  | 122d | 2007-04-09 | 2007-09-28 | 1132095 | 1d | 0d | ELEC ENG [545.03 h]; CONTRB UNIV LBR [479.62 h]; PROCUREMENT<$50K 60; SCIENTIST [261.61 h] | 60,828.48 | 2007-09-28 | ELOUADRHIRI L |  | 1 | 1 | 1.1.3.2 | LATIFA E |  |  |  |  |  |  |  |  |
| 1132050 |  | FY07-EC - Assembly & testing of the protoptype (DTCTR R&D) |  | 103d | 2007-05-04 | 2007-09-28 | 1132045 | 1d | 0d | VISTNG USERS [523.2 h]; MECH TECH [222.8 h] | 17,428.09 | 2007-09-28 | ELOUADRHIRI L |  | 1 | 1 | 1.1.3.2 | LATIFA E |  |  |  |  |  |  |  |  |
| 1132030M |  | FY07-HTCC -R&D Report (DTCTR R&D) | milestone | 0d | 2007-09-28 | 2007-09-28 | 1132030 | 1d | 0d |  |  | 2007-09-28 | ELOUADRHIRI L |  | 1 | 1 | 1.1.3.2 | LATIFA E | 4 |  |  |  |  |  |  |  |
| 1132050M |  | FY07-EC -R&D Report (DTCTR R&D) | milestone | 0d | 2007-09-28 | 2007-09-28 | 1132050 | 1d | 0d |  |  | 2007-09-28 | ELOUADRHIRI L |  | 1 | 1 | 1.1.3.2 | LATIFA E | 4 |  |  |  |  |  |  |  |
| 1132065M |  | FY07-DC -R&D Report (DTCTR R&D) | milestone | 0d | 2007-09-28 | 2007-09-28 | 1132065 | 1d | 0d |  |  | 2007-09-28 | ELOUADRHIRI L |  | 1 | 1 | 1.1.3.2 | LATIFA E | 4 |  |  |  |  |  |  |  |
| 1132075M |  | FY07-FTOF -R&D Report (DTCTR R&D) | milestone | 0d | 2007-09-28 | 2007-09-28 | 1132075 | 1d | 0d |  |  | 2007-09-28 | ELOUADRHIRI L |  | 1 | 1 | 1.1.3.2 | LATIFA E | 4 |  |  |  |  |  |  |  |
| 1132090M |  | FY07-CTOF-R&D Report (DTCTR R&D) | milestone | 0d | 2007-09-28 | 2007-09-28 | 1132090 | 1d | 0d |  |  | 2007-09-28 | ELOUADRHIRI L |  | 1 | 1 | 1.1.3.2 | LATIFA E | 4 |  |  |  |  |  |  |  |
| 1132100M |  | FY07-SVT -R&D Report (DTCTR R&D) | milestone | 0d | 2007-09-28 | 2007-09-28 | 1132100 | 1d | 0d |  |  | 2007-09-28 | ELOUADRHIRI L |  | 1 | 1 | 1.1.3.2 | LATIFA E | 4 |  |  |  |  |  |  |  |
| 1132805 |  | FY08-EC - Fullscale Proto Dsgn (DETCTR R&D) |  | 79d | 2007-10-01 | 2008-01-31 | 1132834M, 1132050M | 1d | 0d | SCIENTIST [8 h]; CONTRB UNIV LBR [32 h]; PD UNIV STUDNT [60 h] | 1,062.76 |  | ELOUADRHIRI L |  | 1 | 1 | 1.1.3.2 | LATIFA E |  |  |  |  |  |  |  |  |
| 1132820 |  | FY08-DC - Mech protoptyping (DETCTR R&D) |  | 125d | 2007-10-01 | 2008-04-07 | 1132065M, 1132854M | 1d | 0d | MECH DES [64 h]; MECH ENG [8 h]; PROCUREMENT<$50K 60; CONTRB UNIV LBR [144 h]; MECH TECH [144 h] | 17,557.16 |  | ELOUADRHIRI L |  | 1 | 1 | 1.1.3.2 | LATIFA E |  |  |  |  |  |  |  |  |
| 1132825 |  | FY08-DC - Elect Prototypng (DETCTR R&D) |  | 125d | 2007-10-01 | 2008-04-07 | 1132065M | 1d | 0d | ELEC TECH [32 h]; ELEC ENG [8 h]; PROCUREMENT<$50K 60; ELEC DES [80 h] | 10,529.09 |  | ELOUADRHIRI L |  | 1 | 1 | 1.1.3.2 | LATIFA E |  |  |  |  |  |  |  |  |
| 1132827M |  | FY08-HTCC -R&D Plans & Initl Sfty Assessmnt (DETCTR R&D) | milestone | 0d | 2007-10-01 | 2007-10-01 | 9-080M, 1132030M | 1d | 0d |  |  |  | ELOUADRHIRI L |  | 1 | 1 | 1.1.3.2 | LATIFA E | 6 |  |  |  |  |  |  |  |
| 1132829 |  | FY08-HTCC - Testing of Proto (DETCTR R&D) |  | 61d | 2007-10-01 | 2008-01-04 | 1132827M | 1d | 0d | SCIENTIST [12 h]; CONTRB UNIV LBR [36 h]; PD UNIV STUDNT [64 h] | 1,349.48 |  | ELOUADRHIRI L |  | 1 | 1 | 1.1.3.2 | LATIFA E |  |  | FY08 |  |  |  |  |  |
| 1132834M |  | FY08-EC -R&D Plans & Initl Sfty Assessmnt (DETCTR R&D) | milestone | 0d | 2007-10-01 | 2007-10-01 | 9-080M | 1d | 0d |  |  |  | ELOUADRHIRI L |  | 1 | 1 | 1.1.3.2 | LATIFA E | 6 |  |  |  |  |  |  |  |
| 1132835 |  | FY08-FTOF - Fab Proto (DETCTR R&D) |  | 98d | 2007-10-01 | 2008-02-28 | 1132869M | 1d | 0d | PROCUREMENT<$50K 60 | 5,221.41 |  | ELOUADRHIRI L |  | 1 | 1 | 1.1.3.2 | LATIFA E |  |  |  |  |  |  |  |  |
| 1132845 |  | FY08-CTOF - Dsgn of Proto (DETCTR R&D) |  | 55d | 2007-10-01 | 2007-12-18 | 1132879M | 1d | 0d |  |  |  | ELOUADRHIRI L |  | 1 | 1 | 1.1.3.2 | LATIFA E |  |  |  |  |  |  |  |  |
| 1132854M |  | FY08-DC Plans & Initl Sfty Assessmnt (DETCTR R&D) | milestone | 0d | 2007-10-01 | 2007-10-01 | 9-080M | 1d | 0d |  |  |  | ELOUADRHIRI L |  | 1 | 1 | 1.1.3.2 | LATIFA E | 6 |  |  |  |  |  |  |  |
| 1132860 |  | FY08-SVT - Prototypng (DETCTR R&D) |  | 125d | 2007-10-01 | 2008-04-07 | 1132894M | 1d | 0d | CONTRB UNIV LBR [144 h]; PROCUREMENT<$50K 60; ELEC ENG [164 h]; SCIENTIST [12 h] | 18,755.76 |  | ELOUADRHIRI L |  | 1 | 1 | 1.1.3.2 | LATIFA E |  |  |  |  |  |  |  |  |
| 1132869M |  | FY08-FTOF -R&D Plans & Initl Sfty Assessmnt (DETCTR R&D) | milestone | 0d | 2007-10-01 | 2007-10-01 | 1132075M | 1d | 0d |  |  |  | ELOUADRHIRI L |  | 1 | 1 | 1.1.3.2 | LATIFA E | 6 |  |  |  |  |  |  |  |
| 1132879M |  | FY08-CTOF -R&D Plans & Initl Sfty Assessmnt (DETCTR R&D) | milestone | 0d | 2007-10-01 | 2007-10-01 | 1132090M | 1d | 0d |  |  |  | ELOUADRHIRI L |  | 1 | 1 | 1.1.3.2 | LATIFA E | 6 |  |  |  |  |  |  |  |
| 1132894M |  | FY08-SVT -R&D Plans & Initl Sfty Assessmnt (DETCTR R&D) | milestone | 0d | 2007-10-01 | 2007-10-01 | 1132100M | 1d | 0d |  |  |  | ELOUADRHIRI L |  | 1 | 1 | 1.1.3.2 | LATIFA E | 6 |  |  |  |  |  |  |  |
| 1132895 |  | FY08-DC- Protoype Testing & Data Analysis (DETCTR R&D) |  | 150d | 2007-10-01 | 2008-05-12 | 9-080M, 1132894M | 56d |  | CONTRB UNIV LBR [1120 h]; PD UNIV STUDNT [16 h]; MECH ENG [12 h]; SCIENTIST [160 h]; VISTNG USERS [280 h]; MECH TECH [40 h]; COMP SCIENT [20 h] | 18,352.44 |  | ELOUADRHIRI L |  | 1 | 1 | 1.1.3.2 | LATIFA E |  |  |  | 07-027 |  |  |  |  |
| 1132897 |  | FY08-SVT- Protoype Testing & Data Analysis (DETCTR R&D) |  | 150d | 2007-10-01 | 2008-05-12 | 1132894M, 9-080M | 98d | 0d | COMP SCIENT [20 h]; MECH TECH [80 h]; SCIENTIST [132 h]; ELEC TECH [16 h]; CONTRB UNIV LBR [1188 h]; VISTNG USERS [788 h] | 26,563.44 |  | ELOUADRHIRI L |  | 1 | 1 | 1.1.3.2 | LATIFA E |  |  |  |  |  |  |  |  |
| 1132850 |  | FY08-CTOF - Fab Proto (DETCTR R&D) |  | 67d | 2007-12-19 | 2008-04-02 | 1132845 | 1d | 0d |  |  |  | ELOUADRHIRI L |  | 1 | 1 | 1.1.3.2 | LATIFA E |  |  |  |  |  |  |  |  |
| 1132841 |  | FY08-HTCC - Analysis of Proto (DETCTR R&D) |  | 186d | 2008-01-07 | 2008-09-29 | 1132829 | 1d | 0d | SCIENTIST [8 h]; CONTRB UNIV LBR [32 h]; PD UNIV STUDNT [60 h] | 1,062.76 |  | ELOUADRHIRI L |  | 1 | 1 | 1.1.3.2 | LATIFA E |  |  |  |  |  |  |  |  |
| 1132810 |  | FY08-EC - Manufacturing Box & Fixtures for Full Scale Proto (DETCTR R&D) |  | 65d | 2008-02-01 | 2008-05-02 | 1132805 | 1d | 0d | MECH TECH [80 h]; PROCUREMENT<$50K 60; MECH DES [12 h]; MECH ENG [8 h] | 12,839.4 |  | ELOUADRHIRI L |  | 1 | 1 | 1.1.3.2 | LATIFA E |  |  |  |  |  |  |  |  |
| 1132840 |  | FY08-FTOF - Testing & Data Analysis from Proto (DETCTR R&D) |  | 149d | 2008-02-29 | 2008-09-29 | 1132835 | 1d | 0d | PROCUREMENT<$50K 60 | 3,477.5 |  | ELOUADRHIRI L |  | 1 | 1 | 1.1.3.2 | LATIFA E |  |  |  |  |  |  |  |  |
| 1132900 |  | SVT Readout (DETCTR R&D) |  | 128d | 2008-04-01 | 2008-09-30 | 9-080M FS+120d | 0d |  | PROCUREMENT<$50K 60; TRAVEL; ELEC ENG [200 h]; ELEC TECH [280 h] | 78,348.4 |  | ELOUADRHIRI L |  | 1 | 1 | 1.1.3.2 | LATIFA E |  |  |  |  | 08-021 |  |  |  |
| 1132905 |  | CTOF PMT's & Mag Sheild Tests (DETCTR R&D) |  | 128d | 2008-04-01 | 2008-09-30 | 9-080M FS+120d | 0d |  | SCIENTIST [320 h]; PROCUREMENT<$50K 60 | 37,926.4 |  | ELOUADRHIRI L |  | 1 | 1 | 1.1.3.2 | LATIFA E |  |  |  |  |  | 08-022 |  |  |
| 1132855 |  | FY08-CTOF - Testing of Proto (DETCTR R&D) |  | 125d | 2008-04-03 | 2008-09-29 | 1132845, 1132850 | 1d | 0d | TRAVEL | 5,159.5 |  | ELOUADRHIRI L |  | 1 | 1 | 1.1.3.2 | LATIFA E |  |  |  |  |  |  |  |  |
| 1132830 |  | FY08-DC - Testing & Analysis of Proto (DETCTR R&D) |  | 122d | 2008-04-08 | 2008-09-29 | 1132825, 1132820 | 1d | 0d | ELEC TECH [32 h]; ELEC ENG [8 h]; ELEC DES [80 h] | 5,307.68 |  | ELOUADRHIRI L |  | 1 | 1 | 1.1.3.2 | LATIFA E |  |  |  |  |  |  |  |  |
| 1132865 |  | FY08-SVT - Testing of Proto (DETCTR R&D) |  | 122d | 2008-04-08 | 2008-09-29 | 1132860 | 1d | 0d | SCIENTIST [80 h]; ELEC ENG [164 h]; CONTRB UNIV LBR [144 h]; PROCUREMENT<$50K 60 | 18,666.46 |  | ELOUADRHIRI L |  | 1 | 1 | 1.1.3.2 | LATIFA E |  |  |  |  |  |  |  |  |
| 1132815 |  | FY08-EC - Assy & Testing of protoptype (DETCTR R&D) |  | 103d | 2008-05-05 | 2008-09-29 | 1132810 | 1d | 0d | MECH TECH [104.19 h]; VISTNG USERS [156 h] | 6,742.57 |  | ELOUADRHIRI L |  | 1 | 1 | 1.1.3.2 | LATIFA E |  |  |  |  |  |  |  |  |
| 1132800M |  | FY08-SVT -R&D Report (DETCTR R&D) | milestone | 0d | 2008-09-29 | 2008-09-29 | 1132865 | 1d |  |  |  |  | ELOUADRHIRI L |  | 1 | 1 | 1.1.3.2 | LATIFA E | 6 |  |  | 07-027 |  |  |  |  |
| 1132831M |  | FY08-HTCC -R&D Report (DETCTR R&D) | milestone | 0d | 2008-09-29 | 2008-09-29 | 1132841 | 1d | 0d |  |  |  | ELOUADRHIRI L |  | 1 | 1 | 1.1.3.2 | LATIFA E | 6 |  |  |  |  |  |  |  |
| 1132851M |  | FY08-EC -R&D Report (DETCTR R&D) | milestone | 0d | 2008-09-29 | 2008-09-29 | 1132815 | 1d | 0d |  |  |  | ELOUADRHIRI L |  | 1 | 1 | 1.1.3.2 | LATIFA E | 6 |  |  |  |  |  |  |  |
| 1132865M |  | FY08-DC -R&D Report (DETCTR R&D) | milestone | 0d | 2008-09-29 | 2008-09-29 | 1132830 | 1d | 0d |  |  |  | ELOUADRHIRI L |  | 1 | 1 | 1.1.3.2 | LATIFA E | 6 |  |  |  |  |  |  |  |
| 1132875M |  | FY08-FTOF -R&D Report (DETCTR R&D) | milestone | 0d | 2008-09-29 | 2008-09-29 | 1132840 | 1d |  |  |  |  | ELOUADRHIRI L |  | 1 | 1 | 1.1.3.2 | LATIFA E | 6 |  |  | 07-027 |  |  |  |  |
| 1132890M |  | FY08-CTOF-R&D Report (DETCTR R&D) | milestone | 0d | 2008-09-29 | 2008-09-29 | 1132855 | 1d | 0d |  |  |  | ELOUADRHIRI L |  | 1 | 1 | 1.1.3.2 | LATIFA E | 6 |  |  |  |  |  |  |  |
| 1132910 |  | Re-Baseline Actuals Adjustment |  | 1d | 2013-08-30 | 2013-08-30 | 9-130M FS+227d | 20d |  | PROCUREMENT>$50K 69 NO ESCALATION | 32,649.09 |  | ELOUADRHIRI L |  | 1 | 1 |  | LATIFA E |  |  |  |  |  |  | 13-014 | ADJ |

Notes:
- 1132825: Current Status: Added Predecessor "Start of / FY08R&D"
- 1132827M: Current Status: Added Predecessor "Start of / FY08R&D"
- 1132834M: Current Status: Added Predecessor Start of FY08 R&D
- 1132854M: Current Status: Added Predecessor "Start of / FY08R&D"
- 1132869M: Current Status: Added Predecessor "Start of / FY08R&D"
- 1132879M: Current Status: Added Predecessor "Start of / FY08R&D"
- 1132894M: Current Status: Added Predecessor "Start of / FY08R&D"

| ID | WBS | Activity | Type | Duration | Start | Finish | Predecessors | Total float | Free float | Constraint | Resources | Cost | Planned FinishUDF | RESP - Responsibility | STRT%COMP for CM EVM | FNSH%COMP for CM EVM | WBS ASSIGNMENT | CAM RESPONSIBLE | Milestone Level | CR 07-027 | CR 13-014 | ReBaseline Actuals Adjustment | Special | CR 07-016 | CR 09-012 | CR 07-017 | CR 08-013 | CR 08-028 |
| --- | --- | --- | --- | --- | --- | --- | --- | --- | --- | --- | --- | --- | --- | --- | --- | --- | --- | --- | --- | --- | --- | --- | --- | --- | --- | --- | --- | --- |
|  | 3 | **1.1.3.3 COMPUTING R&D** |  |  |  |  |  |  |  |  |  |  |  |  |  |  |  |  |  |  |  |  |  |  |  |  |  |  |
|  | 4 | **1.1.3.4 ELECTRONICS** |  |  |  |  |  |  |  |  |  |  |  |  |  |  |  |  |  |  |  |  |  |  |  |  |  |  |
|  | 5 | **1.1.3.5 BEAMLINE** |  |  | 2006-10-02 | 2013-08-30 |  |  |  |  |  |  |  |  |  |  |  |  |  |  |  |  |  |  |  |  |  |  |
| 1135010 |  | BL - Conduct rates studies and beam line optimization at HTCC (BEAMLINE) |  | 125d | 2006-10-02 | 2007-04-06 | 9-070M | 203d | 24d |  | VISTNG USERS [906.02 h]; TRAVEL | 17,657.57 | 2007-04-06 | ELOUADRHIRI L | 1 | 1 | 1.1.3.5 | LATIFA E |  |  |  |  |  |  |  |  |  |  |
| 1135015 |  | BL - Conduct rates studies and optimization of the beam line at FDC (BEAMLINE) |  | 149d | 2006-10-02 | 2007-05-10 | 9-070M | 179d | 0d |  | TRAVEL; VISTNG USERS [906.02 h] | 17,657.57 | 2007-05-10 | ELOUADRHIRI L | 1 | 1 | 1.1.3.5 | LATIFA E |  |  |  |  |  |  |  |  |  |  |
| 1135020M |  | BL -R&D Report (BEAMLINE) | milestone | 0d | 2007-05-11 | 2007-05-11 | 1135010, 1135015 | 179d | 156d |  |  |  | 2007-05-11 | ELOUADRHIRI L | 1 | 1 | 1.1.3.5 | LATIFA E | 4 |  |  |  |  |  |  |  |  |  |
| 1135025 |  | BL- Rates Studies & Beam Line Optimztn of Forward Detctr |  | 125d | 2008-01-02 | 2008-06-27 | 1135020M, 9-080M FS+58d | 23d | 0d |  | VISTNG USERS [540 h]; SCIENTIST [544 h] | 43,076.48 |  | ELOUADRHIRI L | 1 | 1 | 1.1.3.5 | LATIFA E |  | 07-027 |  |  |  |  |  |  |  |  |
| 1135030 |  | Re-Baseline Actuals Adjustment |  | 1d | 2013-08-30 | 2013-08-30 | 9-130M FS+227d | 20d |  |  | PROCUREMENT>$50K 69 NO ESCALATION | -11,289.71 |  | ELOUADRHIRI L | 1 | 1 |  | LATIFA E |  |  | 13-014 | ADJ |  |  |  |  |  |  |
|  | 6 | **1.1.3.6 INFRASTRUCTURE** |  |  |  |  |  |  |  |  |  |  |  |  |  |  |  |  |  |  |  |  |  |  |  |  |  |  |
|  | 4 | **1.1.4 HALL C** |  |  | 2006-10-02 | 2013-08-30 |  |  |  |  |  |  |  |  |  |  |  |  |  |  |  |  |  |  |  |  |  |  |
|  | 1 | **1.1.4.1 MAGNET** |  |  | 2006-10-02 | 2013-08-30 |  |  |  |  |  |  |  |  |  |  |  |  |  |  |  |  |  |  |  |  |  |  |
| 1141005RKC |  | FY06 Obligations RKC |  | 120d | 2006-10-02 | 2007-03-30 | 9-070M | 333d |  |  | PROCUREMENT<$50K 60; PROCUREMENT>$50K 69 | 73,801.42 | 2007-03-30 | PARKINSON J | 1 | 1 | 1.1.4.1 | HOWARD F |  |  |  |  | LR |  |  |  |  |  |
| 1141015 |  | Build a Test Device to Measure Heat Distribution at the HB Magnet |  | 163d | 2006-10-02 | 2007-05-31 | 9-070M | 100d | 43d |  | PROCUREMENT<$50K 60; MECH ENG [120 h]; TRAVEL; VISTNG USERS [360 h] | 25,999.66 | 2007-05-31 | FENKER H | 1 | 1 | 1.1.4.1 | HOWARD F |  |  |  |  |  |  |  |  |  |  |
| 1141020 |  | Cable reshaping and testing for HB and Q1 magnets |  | 129d | 2006-10-02 | 2007-04-12 | 9-070M | 134d | 77d |  | PROCUREMENT<$50K 60 | 49,796 | 2007-07-31 | FENKER H | 1 | 1 | 1.1.4.1 | HOWARD F |  |  |  |  |  | 07-016 | 09-012 |  |  |  |
| 1141010 |  | Design a scale cross section model of the HB magnet FY 07 |  | 84d | 2007-06-01 | 2007-09-28 | 9-070M | 0d |  | start on or after 2007-06-01 | MECH ENG [160 h]; TRAVEL | 13,113.22 | 2007-05-31 | FENKER H | 1 | 1 | 1.1.4.1 | HOWARD F |  |  |  |  |  |  |  | 07-017 |  |  |
| 1141011 |  | Design a scale cross section model of the HB magnet FY 08 |  | 142d | 2007-10-01 | 2008-04-30 | 1141010 | 86d | 29d |  | MECH ENG [80 h]; TRAVEL | 6,722.07 | 2007-05-31 | FENKER H | 1 | 1 | 1.1.4.1 | HOWARD F |  | 07-027 |  |  |  |  |  | 07-017 |  |  |
| 1141013 |  | Prepare Tooling for Coil Winding & Wind Several Subcoils for the HB Magnet |  | 99d | 2007-12-03 | 2008-04-30 | 1141010 FS+43d | 0d |  |  | PROCUREMENT<$50K 60 | 18,574.2 | 2007-05-31 | FENKER H | 1 | 1 | 1.1.4.1 | HOWARD F |  | 07-027 |  |  |  |  |  | 07-017 | 08-013 |  |
| 1141012 |  | Fab 1 full HB Coil & Test Mech, Elect & Insulation Properities @ Room Temp |  | 106d | 2008-05-01 | 2008-09-30 | 1141010, 1141013 | 0d |  |  | PROCUREMENT<$50K 60 | 18,698.03 | 2007-05-31 | FENKER H | 1 | 1 | 1.1.4.1 | HOWARD F |  | 07-027 |  |  |  |  |  | 07-017 | 08-013 |  |
| 1141025 |  | Re-Baseline Actuals Adjustment |  | 1d | 2013-08-30 | 2013-08-30 | 9-130M FS+227d | 20d |  |  | PROCUREMENT>$50K 69 NO ESCALATION | 48,066.02 |  | FENKER H | 1 | 1 |  | HOWARD F |  |  | 13-014 | ADJ |  |  |  |  |  |  |
|  | 2 | **1.1.4.2 DETECTOR** |  |  | 2006-10-02 | 2013-08-30 |  |  |  |  |  |  |  |  |  |  |  |  |  |  |  |  |  |  |  |  |  |  |
| 1141005RKC5 |  | FY06 Obligations RKC |  | 120d | 2006-10-02 | 2007-03-30 | 9-070M | 333d |  |  | SUPPLIES & MATERIALS | 6,047.52 | 2007-03-30 | PARKINSON J | 1 | 1 | 1.1.4.2 | HOWARD F |  |  |  |  | LR |  |  |  |  |  |
| 1142020 |  | Continue exploration of alternative calorimeter designs (DTCTR) |  | 195d | 2006-10-02 | 2007-07-17 | 9-070M | 425d | 360d |  | TRAVEL; VISTNG USERS [1040 h] | 19,923.79 | 2007-07-17 | FENKER H | 1 | 1 | 1.1.4.2 | HOWARD F |  |  |  |  |  |  |  |  |  |  |
| 1142025 |  | In beam test of new prototype quartz hodoscope (DTCTR) |  | 130d | 2006-10-02 | 2007-04-13 | 9-070M | 353d | 20d |  | TRAVEL; PD UNIV STUDNT [320 h]; VISTNG USERS [1480 h]; PROCUREMENT<$50K 60; SCIENTIST [400 h] | 67,210.12 | 2007-04-13 | FENKER H | 1 | 1 | 1.1.4.2 | HOWARD F |  |  |  |  |  |  |  |  |  |  |
| 1142030 |  | Test Blocks & PMT's and Map Out Optmal Placement (DTCTR) |  | 65d | 2008-04-08 | 2008-07-09 | 9-080M FS+125d | 58d |  |  | VISTNG USERS [880 h] | 14,995.2 | 2007-04-13 | FENKER H | 1 | 1 | 1.1.4.2 | HOWARD F |  |  |  |  |  |  |  |  |  | 08-028 |
| 1142035 |  | Re-Baseline Actuals Adjustment |  | 1d | 2013-08-30 | 2013-08-30 | 9-130M FS+227d | 20d |  |  | PROCUREMENT>$50K 69 NO ESCALATION | -44,437.94 |  | FENKER H | 1 | 1 |  | HOWARD F |  |  | 13-014 | ADJ |  |  |  |  |  |  |

| ID | WBS | Activity | Duration | Start | Finish | Predecessors | Total float | Free float | Constraint | Resources | Cost | Planned FinishUDF | RESP - Responsibility | Special | STRT%COMP for CM EVM | FNSH%COMP for CM EVM | CR 07-014 | WBS ASSIGNMENT | CAM RESPONSIBLE | CR 09-012 | CR 08-016 | CR 07-027 | CR 08-020 | CR 13-014 | ReBaseline Actuals Adjustment | CR 10-042 |
| --- | --- | --- | --- | --- | --- | --- | --- | --- | --- | --- | --- | --- | --- | --- | --- | --- | --- | --- | --- | --- | --- | --- | --- | --- | --- | --- |
|  | 3 | **1.1.4.3 COMPUTING** |  |  |  |  |  |  |  |  |  |  |  |  |  |  |  |  |  |  |  |  |  |  |  |  |
|  | 4 | **1.1.4.4 ELECTRONICS** |  |  |  |  |  |  |  |  |  |  |  |  |  |  |  |  |  |  |  |  |  |  |  |  |
|  | 5 | **1.1.4.5 BEAMLINE** |  |  |  |  |  |  |  |  |  |  |  |  |  |  |  |  |  |  |  |  |  |  |  |  |
|  | 6 | **1.1.4.6 INFRASTRUCTURE** |  |  |  |  |  |  |  |  |  |  |  |  |  |  |  |  |  |  |  |  |  |  |  |  |
|  | 5 | **1.1.5 HALL D** |  | 2006-10-02 | 2013-08-30 |  |  |  |  |  |  |  |  |  |  |  |  |  |  |  |  |  |  |  |  |  |
|  | 1 | **1.1.5.1 MAGNET** |  |  |  |  |  |  |  |  |  |  |  |  |  |  |  |  |  |  |  |  |  |  |  |  |
|  | 2 | **1.1.5.2 DETECTOR** |  | 2006-10-02 | 2013-08-30 |  |  |  |  |  |  |  |  |  |  |  |  |  |  |  |  |  |  |  |  |  |
| 1152001RKC |  | FY06 Obligations RKC | 120d | 2006-10-02 | 2007-03-30 | 9-070M | 333d |  |  | PLABOR; PROCUREMENT>$50K 69; SUPPLIES & MATERIALS; PROCUREMENT<$50K 60 | 96,964.66 | 2007-03-30 | PARKINSON J | LR | 1 | 1 | 07-014 | 1.1.5.2 | ELKE A |  |  |  |  |  |  |  |
| 1152005 |  | Drift chamber prototyping (DTCTR) | 80d | 2006-10-02 | 2007-02-01 | 9-070M | 206d | 0d |  | SCIENTIST [904 h]; MECH TECH [910 h]; CONTRB UNIV LBR [261.6 h] | 94,227.56 | 2007-09-28 | CHUDAKOV |  | 1 | 1 | 07-014 | 1.1.5.2 | EUGENE C | 09-012 |  |  |  |  |  |  |
| 1152010 |  | BCAL prototyping (DTCTR) | 80d | 2006-10-02 | 2007-02-01 | 9-070M | 462d | 0d |  | MECH ENG [335.2 h]; CONTRB UNIV LBR [379.2 h] | 20,701.95 | 2007-09-28 | CHUDAKOV |  | 1 | 1 | 07-014 | 1.1.5.2 | EUGENE C | 09-012 |  |  |  |  |  |  |
| 1152015LOE |  | BCAL postdoc (DTCTR) | 79d | 2006-10-02 | 2007-02-01 | 9-070M | 591d | 0d |  | PD UNIV STAFF [562.8 h] | 28,156.87 | 2007-03-30 | CHUDAKOV |  | 1 | 1 | 07-014 | 1.1.5.2 | EUGENE C |  |  |  |  |  |  |  |
| 1152020 |  | UPV prototyping (DTCTR) | 247d | 2006-10-02 | 2007-09-28 | 9-070M | 353d | 0d |  | PROCUREMENT<$50K 60 | 20,640 | 2007-09-28 | CHUDAKOV |  | 1 | 1 | 07-014 | 1.1.5.2 | EUGENE C | 09-012 |  |  |  |  |  |  |
| 1152025 |  | CER prototyping (DTCTR) | 79d | 2006-10-02 | 2007-02-01 | 9-070M | 354d | 0d |  |  |  | 2007-09-28 | CHUDAKOV |  | 1 | 1 | 07-014 | 1.1.5.2 | EUGENE C | 09-012 |  |  |  |  |  |  |
| 1152015LOEA |  | BCAL postdoc (DTCTR) | 40d | 2007-02-01 | 2007-03-30 | 1152015LOE | 591d | 129d | start on or after 2007-02-01 |  |  | 2007-03-30 | CHUDAKOV |  | 1 | 1 | 07-014 | 1.1.5.2 | EUGENE C | 09-012 |  |  |  |  |  |  |
| 1152025A |  | CER prototyping (DTCTR) | 167d | 2007-02-01 | 2007-09-28 | 1152025 | 354d | 1d | start on or after 2007-02-01 | PROCUREMENT<$50K 60 | 41,280 | 2007-09-28 | CHUDAKOV |  | 1 | 1 | 07-014 | 1.1.5.2 | EUGENE C | 09-012 |  |  |  |  |  |  |
| 1152005A |  | Drift chamber prototyping (DTCTR) | 167d | 2007-02-02 | 2007-09-28 | 1152005 | 206d |  | start on or after 2007-02-02 | MECH DES [520 h]; MECH ENG [1080 h]; PROCUREMENT<$50K 60; PD UNIV STAFF [360 h]; SCIENTIST [240 h]; ELEC DES [440 h] | 285,092.11 | 2007-09-28 | CHUDAKOV |  | 1 | 1 | 07-014 | 1.1.5.2 | EUGENE C | 09-012 |  |  |  |  |  |  |
| 1152010A |  | BCAL prototyping (DTCTR) | 168d | 2007-02-02 | 2007-10-01 | 1152010 | 462d | 0d | start on or after 2007-02-02 | PROCUREMENT<$50K 60 NO ESCALATION FY08; PD UNIV STAFF [680 h]; SCIENTIST [640 h] | 137,481.13 | 2007-09-28 | CHUDAKOV |  | 1 | 1 | 07-014 | 1.1.5.2 | EUGENE C | 09-012 | 08-016 |  |  |  |  |  |
| 1152040 |  | BCAL Evaluation & Testing of Module 2 (H-D DETCTR) | 115d | 2007-10-01 | 2008-03-24 | 9-080M | 42d | 0d |  | PROCUREMENT<$50K 60; CONTRB UNIV LBR [1840 h] | 87,319.38 |  | CHUDAKOV |  | 1 | 1 |  | 1.1.5.2 | EUGENE C |  |  |  |  |  |  |  |
| 1152945LOE |  | FY08 UPV University Supprt (H-D DETCTR) | 248d | 2007-10-01 | 2008-09-30 | 9-080M | 0d |  |  | CONTRB UNIV LBR [1120 h] |  |  | CHUDAKOV |  | 1 | 1 |  | 1.1.5.2 | EUGENE C |  |  |  |  |  |  |  |
| 1152030 |  | FY08 DC Chamb Prototypng (H-D DETCTR) | 220d | 2007-11-07 | 2008-09-29 | 9-080M FS+27d | 1d | 0d |  | CONTRB UNIV LBR [1160 h]; SCIENTIST [1440 h] | 89,668.8 |  | CHUDAKOV |  | 1 | 1 |  | 1.1.5.2 | EUGENE C |  |  | 07-027 |  |  |  |  |
| 1152035 |  | CDC University Supprt (H-D DETCTR) | 220d | 2007-11-07 | 2008-09-29 | 9-080M FS+27d | 1d | 0d |  | CONTRB UNIV LBR [2680 h] |  |  | CHUDAKOV |  | 1 | 1 |  | 1.1.5.2 | EUGENE C |  |  |  |  |  |  |  |
| 1152055 |  | Invstg common solutn for Gain Monitrng/Calibr Sys in H-D for Calirim's & TOF | 149d | 2008-03-03 | 2008-09-30 | 9-080M FS+99d | 0d |  |  | PROCUREMENT<$50K 60; SCIENTIST [113.6 h] | 37,073.87 |  | CHUDAKOV |  | 1 | 1 |  | 1.1.5.2 | EUGENE C | 09-012 |  |  | 08-020 |  |  |  |
| 1152060 |  | Re-Baseline Actuals Adjustment | 1d | 2013-08-30 | 2013-08-30 | 9-130M FS+227d | 20d |  |  | PROCUREMENT>$50K 69 NO ESCALATION | 88,011.48 |  | CHUDAKOV |  | 1 | 1 |  |  | EUGENE C |  |  |  |  | 13-014 | ADJ |  |
|  | 3 | **1.1.5.3 COMPUTING** |  |  |  |  |  |  |  |  |  |  |  |  |  |  |  |  |  |  |  |  |  |  |  |  |
|  | 4 | **1.1.5.4 ELECTRONICS** |  | 2006-10-02 | 2013-08-30 |  |  |  |  |  |  |  |  |  |  |  |  |  |  |  |  |  |  |  |  |  |
| 1154001RKC |  | FY06 Obligations RKC | 120d | 2006-10-02 | 2007-03-30 | 9-070M | 333d |  |  | SUPPLIES & MATERIALS | 7,989.74 | 2007-03-30 | PARKINSON J | LR | 1 | 1 | 07-014 | 1.1.5.4 | ELKE A |  |  |  |  |  |  |  |
| 1154005 |  | FADC development (ELCTRNICS) | 79d | 2006-10-02 | 2007-02-01 | 9-070M | 114d | 1d |  | SCIENTIST [160.8 h] | 10,321.75 | 2007-09-28 | CHUDAKOV |  | 1 | 1 | 07-014 | 1.1.5.4 | EUGENE C | 09-012 |  |  |  |  |  |  |
| 1154010 |  | Trigger development (ELCTRNICS) | 79d | 2006-10-02 | 2007-02-01 | 9-070M | 454d | 1d |  |  |  | 2007-09-28 | CHUDAKOV |  | 1 | 1 | 07-014 | 1.1.5.4 | EUGENE C | 09-012 |  |  |  |  |  |  |
| 1154005A |  | FADC development (ELCTRNICS) | 167d | 2007-02-02 | 2007-09-28 | 1154005 | 113d | 0d | start on or after 2007-02-02 | PROCUREMENT<$50K 60 | 51,600 | 2007-09-28 | CHUDAKOV |  | 1 | 1 | 07-014 | 1.1.5.4 | EUGENE C | 09-012 |  |  |  |  |  |  |
| 1154010A |  | Trigger development (ELCTRNICS) | 167d | 2007-02-02 | 2007-09-28 | 1154010 | 453d | 248d | start on or after 2007-02-02 | VISTNG USERS [1559.2 h]; PROCUREMENT<$50K 60; SCIENTIST [648 h] | 87,560.43 | 2007-09-28 | CHUDAKOV |  | 1 | 1 | 07-014 | 1.1.5.4 | EUGENE C | 09-012 |  |  |  |  |  |  |
| 1154015 |  | Logic & HV Supprt (Electrnc's) | 220d | 2007-10-01 | 2008-08-20 | 9-080M | 3d | 0d |  | CONTRB UNIV LBR [360 h]; PROCUREMENT<$50K 60 | 21,298.42 |  | CHUDAKOV |  | 1 | 1 |  | 1.1.5.4 | EUGENE C |  |  |  |  |  |  |  |
| 1154020 |  | Develop a Clock Distrbtn Sys to FADC Boards (Electrnc's) | 65d | 2007-10-01 | 2008-01-10 | 9-080M | 23d | 0d |  | SCIENTIST [400 h] | 24,908 |  | CHUDAKOV |  | 1 | 1 |  | 1.1.5.4 | EUGENE C |  |  |  |  |  |  | 10-042 |
| 1154025 |  | Develop Clock Distrbtn for TDCs (Electrnc's) | 130d | 2007-10-01 | 2008-04-14 | 9-080M | 76d |  |  | SCIENTIST [560 h] | 34,871.2 |  | CHUDAKOV |  | 1 | 1 |  | 1.1.5.4 | EUGENE C |  |  | 07-027 |  |  |  | 10-042 |
| 1154035 |  | Collection of Track Counts into Trigger (Electrnc's) | 130d | 2007-10-01 | 2008-04-14 | 9-080M | 3d | 0d |  | PROCUREMENT<$50K 60 | 22,361.27 |  | CHUDAKOV |  | 1 | 1 |  | 1.1.5.4 | EUGENE C |  |  |  |  |  |  |  |
| 1154045 |  | Develop Signal Distrbtn to All Crates (Electrnc's) | 130d | 2007-10-01 | 2008-04-14 | 9-080M | 118d |  |  | PROCUREMENT<$50K 60 | 10,649.21 |  | CHUDAKOV |  | 1 | 1 |  | 1.1.5.4 | EUGENE C |  |  |  |  |  |  |  |
| 1154050 |  | Evaluate Backplane Use of Crates for Dataways, especially FADCs (Electrnc's) | 130d | 2007-10-01 | 2008-04-14 | 9-080M | 118d |  |  | CONTRB UNIV LBR [560 h] |  |  | CHUDAKOV |  | 1 | 1 |  | 1.1.5.4 | EUGENE C |  |  |  |  |  |  |  |
| 1154030 |  | Collection of Energy Sums into Trigger (Electrnc's) | 130d | 2008-01-11 | 2008-07-16 | 1154020, 9-080M | 23d | 20d |  | CONTRB UNIV LBR [600 h] |  |  | CHUDAKOV |  | 1 | 1 |  | 1.1.5.4 | EUGENE C |  |  |  |  |  |  | 10-042 |
| 1154040 |  | Proto Dsgn for Master Trigger (Electrnc's) | 130d | 2008-03-25 | 2008-09-25 | 9-080M, 1154035 FS-15d, 1154030 FS-100d | 3d | 0d |  | CONTRB UNIV LBR [600 h] |  |  | CHUDAKOV |  | 1 | 1 |  | 1.1.5.4 | EUGENE C |  |  |  |  |  |  |  |
| 1154055 |  | Specify HV & Low Voltage Supplies (Electrnc's) | 65d | 2008-06-25 | 2008-09-25 | 1154015 FS-40d | 3d |  |  | SCIENTIST [280 h] | 17,435.6 |  | CHUDAKOV |  | 1 | 1 |  | 1.1.5.4 | EUGENE C |  |  |  |  |  |  |  |
| 1154060 |  | Specify Discriminators & Logic for DAQ/Trigger Integration (Electrnc's) | 65d | 2008-06-25 | 2008-09-25 | 1154015 FS-40d | 3d | 0d |  | SCIENTIST [280 h] | 17,435.6 |  | CHUDAKOV |  | 1 | 1 |  | 1.1.5.4 | EUGENE C |  |  |  |  |  |  |  |
| 1154065 |  | Re-Baseline Actuals Adjustment | 1d | 2013-08-30 | 2013-08-30 | 9-130M FS+227d | 20d |  |  | PROCUREMENT>$50K 69 NO ESCALATION | -70,235.81 |  | CHUDAKOV |  | 1 | 1 |  |  | EUGENE C |  |  |  |  | 13-014 | ADJ |  |

| ID | WBS | Activity | Type | Duration | Start | Finish | Predecessors | Total float | Free float | Constraint | Resources | Cost | Planned FinishUDF | RESP - Responsibility | Special | STRT%COMP for CM EVM | FNSH%COMP for CM EVM | CR 07-014 | WBS ASSIGNMENT | CAM RESPONSIBLE | CR 09-012 | CR 07-027 | CR 13-014 | ReBaseline Actuals Adjustment | Milestone Level |
| --- | --- | --- | --- | --- | --- | --- | --- | --- | --- | --- | --- | --- | --- | --- | --- | --- | --- | --- | --- | --- | --- | --- | --- | --- | --- |
|  | 5 | **1.1.5.5 BEAMLINE** |  |  | 2006-10-02 | 2013-08-30 |  |  |  |  |  |  |  |  |  |  |  |  |  |  |  |  |  |  |  |
| 1155001RKC |  | FY06 Obligations RKC |  | 120d | 2006-10-02 | 2007-03-30 | 9-070M | 333d |  |  | SUPPLIES & MATERIALS | 24,496.58 | 2007-03-30 | PARKINSON J | LR | 1 | 1 | 07-014 | 1.1.5.5 | ELKE A |  |  |  |  |  |
| 1155005 |  | Hodoscope prototyping (BEAMLINE) |  | 79d | 2006-10-02 | 2007-02-01 | 9-070M | 174d | 1d |  |  |  | 2007-09-28 | CHUDAKOV |  | 1 | 1 | 07-014 | 1.1.5.5 | EUGENE C | 09-012 |  |  |  |  |
| 1155010 |  | Conduct Diamond studies (BEAMLINE) |  | 80d | 2006-10-02 | 2007-02-01 | 9-070M | 133d | 0d |  | PD UNIV STUDNT [213.2 h] | 2,121.34 | 2007-09-28 | CHUDAKOV |  | 1 | 1 | 07-014 | 1.1.5.5 | EUGENE C | 09-012 |  |  |  |  |
| 1155005A |  | Hodoscope prototyping (BEAMLINE) |  | 167d | 2007-02-02 | 2007-09-28 | 1155005 | 173d | 60d | start on or after 2007-02-02 | PROCUREMENT<$50K 60; PD UNIV STUDNT [3200 h] | 42,987.34 | 2007-09-28 | CHUDAKOV |  | 1 | 1 | 07-014 | 1.1.5.5 | EUGENE C | 09-012 |  |  |  |  |
| 1155010A |  | Conduct Diamond studies (BEAMLINE) |  | 167d | 2007-02-02 | 2007-09-28 | 1155010 | 133d | 41d |  | PD UNIV STUDNT [580 h]; PROCUREMENT<$50K 60 | 24,122.86 | 2007-09-28 | CHUDAKOV |  | 1 | 1 | 07-014 | 1.1.5.5 | EUGENE C |  |  |  |  |  |
| 1155015 |  | Proto SiPM Readout for Microscope (BL) |  | 60d | 2007-10-01 | 2008-01-03 | 9-080M | 86d | 0d |  | PD UNIV STUDNT [880 h] | 8,280.8 |  | CHUDAKOV |  | 1 | 1 |  | 1.1.5.5 | EUGENE C |  | 07-027 |  |  |  |
| 1155025 |  | Proto Mounting Schemes for Thin Crystals (BL) |  | 60d | 2007-10-01 | 2008-01-03 | 9-080M | 146d |  |  | PROCUREMENT<$50K 60 | 5,427.79 |  | CHUDAKOV |  | 1 | 1 |  | 1.1.5.5 | EUGENE C |  |  |  |  |  |
| 1155030 |  | Check Current Sensitivity of Active Collimator Electrnc's (BL) |  | 60d | 2007-10-01 | 2008-01-03 | 9-080M | 146d |  |  | CONTRB UNIV LBR [720 h] |  |  | CHUDAKOV |  | 1 | 1 |  | 1.1.5.5 | EUGENE C |  |  |  |  |  |
| 1155020 |  | Proto Microscope Mounting Frame (BL) |  | 60d | 2008-01-04 | 2008-03-31 | 1155015 | 86d |  |  | PD UNIV STUDNT [880 h] | 8,280.8 |  | CHUDAKOV |  | 1 | 1 |  | 1.1.5.5 | EUGENE C |  | 07-027 |  |  |  |
| 1155035 |  | Re-Baseline Actuals Adjustment |  | 1d | 2013-08-30 | 2013-08-30 | 9-130M FS+227d | 20d |  |  | PROCUREMENT>$50K 69 NO ESCALATION | 154.71 |  | CHUDAKOV |  | 1 | 1 |  |  | EUGENE C |  |  | 13-014 | ADJ |  |
|  | 6 | **1.1.5.6 INFRASTRUCTURE** |  |  |  |  |  |  |  |  |  |  |  |  |  |  |  |  |  |  |  |  |  |  |  |
|  | 7 | **1.1.5.7 CRYOGENICS** |  |  |  |  |  |  |  |  |  |  |  |  |  |  |  |  |  |  |  |  |  |  |  |
|  | 6 | **1.1.6 CIVIL** |  |  | 2013-08-30 | 2013-08-30 |  |  |  |  |  |  |  |  |  |  |  |  |  |  |  |  |  |  |  |
|  | 1 | **1.1.6.1 HALL D** |  |  | 2013-08-30 | 2013-08-30 |  |  |  |  |  |  |  |  |  |  |  |  |  |  |  |  |  |  |  |
| 1161000 |  | Re-Baseline Actuals Adjustment |  | 1d | 2013-08-30 | 2013-08-30 | 9-130M FS+227d | 20d |  |  | PROCUREMENT>$50K 69 NO ESCALATION |  |  | YASKY R |  | 1 | 1 |  |  | REBECCA Y |  |  | 13-014 | ADJ |  |
|  | 7 | **1.1.7 R&D PROJECT MANAGEMENT** |  |  | 2006-10-02 | 2013-08-30 |  |  |  |  |  |  |  |  |  |  |  |  |  |  |  |  |  |  |  |
| 117000LOE |  | FY07 R&D Project Management |  | 247d | 2006-10-02 | 2007-09-28 | 9-070M | 0d |  |  | OFFICE [880 h]; ELEC ENG [360 h]; DIRECTORATE [148 h]; ADMIN [1760 h]; MECH ENG [140 h]; SR STAFF [148 h] | 184,299.09 | 2007-09-28 | RODE C |  | 1 | 1 |  | 1.1.7 | CLAUS R | 09-012 |  |  |  |  |
| 117908LOE |  | FY08 R&D Project Management |  | 248d | 2007-10-01 | 2008-09-30 | 117000LOE | 0d |  |  | SR STAFF [598.4 h]; SCIENTIST [246.4 h]; ADMIN [880 h]; OFFICE [880 h]; MECH ENG [352 h] | 164,489.95 | 2007-09-28 | RODE C |  | 1 | 1 |  | 1.1.7 | CLAUS R | 09-012 |  |  |  |  |
| 117910 |  | Re-Baseline Actuals Adjustment |  | 1d | 2013-08-30 | 2013-08-30 | 9-130M FS+227d | 20d |  |  | PROCUREMENT>$50K 69 NO ESCALATION | 44,494.58 |  | RODE C |  | 1 | 1 |  |  | CLAUS R |  |  | 13-014 | ADJ |  |
|  | 2 | **1.2 PED** |  |  | 2006-10-02 | 2013-08-30 |  |  |  |  |  |  |  |  |  |  |  |  |  |  |  |  |  |  |  |
|  | 1 | **1.2.1 ACCELERATOR SYSTEMS** |  |  | 2006-10-02 | 2013-08-30 |  |  |  |  |  |  |  |  |  |  |  |  |  |  |  |  |  |  |  |
|  | 1 | **1.2.1.1 CRYOMODULES** |  |  | 2006-10-02 | 2013-08-30 |  |  |  |  |  |  |  |  |  |  |  |  |  |  |  |  |  |  |  |
| 1211005M5 |  | FY07 Internal Intermediate Design and Safety Review | milestone | 0d | 2007-06-25 | 2007-06-25 | 111123010M FS+71d | 315d |  |  |  |  | 2006-11-14 | HOGAN J |  | 1 | 1 |  |  | JOHN H |  | 07-027 |  |  | 6 |
| 1211020M |  | FY09 Cvity String Pre-Construction Dsgn & Stfy Review for CM | milestone | 0d | 2009-04-28 | 2009-04-28 | 121116020M, 121111010M, 121113010M, 121115010M | 108d | 0d |  |  |  | 2007-02-13 | HOGAN J |  | 1 | 1 |  |  | JOHN H |  | 07-027 |  |  | 6 |
| 1211020M10 |  | FY09 Cryomodule Pre-construction Dsgn & Sfty Review for CM | milestone | 0d | 2009-09-29 | 2009-09-29 | 121135020M, 121133020M, 121134020M, 121131020M, 121132020M, 121136020M, 121138020M, 121137020M | -24d | 1d |  |  |  | 2007-05-03 | HOGAN J |  | 1 | 1 |  |  | JOHN H |  | 07-027 |  |  | 6 |
| 1211020M15 |  | FY09 Cryomodule Misc Pre-construction Dsgn & Sfty Review for CM | milestone | 0d | 2009-09-29 | 2009-09-29 | 12115005M, 12114005M | 1d |  |  |  |  |  | HOGAN J |  | 1 | 1 |  |  | JOHN H |  | 07-027 |  |  | 6 |
| 1211020M5 |  | FY09 Space Frame Pre-construction Dsgn & Sfty Review for CM | milestone | 0d | 2009-09-29 | 2009-09-29 | 121126020M, 121121010M, 121124020M, 121125020M, 121122010M, 121123010M | 1d | 0d |  |  |  |  | HOGAN J |  | 1 | 1 |  |  | JOHN H |  | 07-027 |  |  | 6 |

| ID | WBS | Activity | Type | Duration | Start | Finish | Predecessors | Total float | Free float | Resources | Cost | RESP - Responsibility | STRT%COMP for CM EVM | FNSH%COMP for CM EVM | CR 07-027 | WBS ASSIGNMENT | CAM RESPONSIBLE | Milestone Level | CR 13-014 | ReBaseline Actuals Adjustment | CR 10-027 | CR 10-064 | CR 11-051 | CR 12-018 | Planned FinishUDF | CR 09-012 |
| --- | --- | --- | --- | --- | --- | --- | --- | --- | --- | --- | --- | --- | --- | --- | --- | --- | --- | --- | --- | --- | --- | --- | --- | --- | --- | --- |
|  | 1 | **1.2.1.1.1 CAVITY STRING ASSEMBLY** |  |  | 2007-08-15 | 2013-08-30 |  |  |  |  |  |  |  |  |  |  |  |  |  |  |  |  |  |  |  |  |
|  | 1 | **1.2.1.1.1.1 CAVITIES** |  |  | 2007-11-12 | 2013-08-30 |  |  |  |  |  |  |  |  |  |  |  |  |  |  |  |  |  |  |  |  |
| 121111005 |  | FY08 Final Dsgn Cavity |  | 140d | 2007-11-12 | 2008-06-10 | 9-080M FS+30d | 36d | 0d | MECH ENG [40 h]; MECH DES [80 h]; ELEC ENG [40 h]; SR STAFF [80 h]; SCIENTIST [40 h]; OFFICE [40 h] | 19,832.4 | HOGAN J | 1 | 1 | 07-027 | 1.2.1.1.1.1 | JOHN H |  |  |  |  |  |  |  |  |  |
| 121111010M |  | FY08 Final Dsgn Comptd for Cavity | milestone | 0d | 2008-06-10 | 2008-06-10 | 121111005 | 36d |  |  |  | HOGAN J | 1 | 1 |  | 1.2.1.1.1.1 | JOHN H | 6 |  |  |  |  |  |  |  |  |
| 121111015 |  | Re-Baseline Actuals Adjustment |  | 1d | 2013-08-30 | 2013-08-30 | 9-130M FS+227d | 20d |  | PROCUREMENT>$50K 69 NO ESCALATION | 30,843.82 | HOGAN J | 1 | 1 |  |  | JOHN H |  | 13-014 | ADJ |  |  |  |  |  |  |
|  | 2 | **1.2.1.1.1.2 NIOBIUM** |  |  |  |  |  |  |  |  |  |  |  |  |  |  |  |  |  |  |  |  |  |  |  |  |
|  | 3 | **1.2.1.1.1.3 FUNDAMENTAL POWER COUPLER** |  |  | 2008-03-13 | 2013-08-30 |  |  |  |  |  |  |  |  |  |  |  |  |  |  |  |  |  |  |  |  |
| 121113005 |  | FY08 Final Dsgn FPC |  | 140d | 2008-03-13 | 2008-09-29 | 9-080M FS+107d | 230d | 0d | MECH DES [120 h]; OFFICE [40 h]; SR STAFF [40 h]; SCIENTIST [40 h]; MECH TECH [80 h]; MECH ENG [80 h] | 20,665.2 | HOGAN J | 1 | 1 | 07-027 | 1.2.1.1.1.3 | JOHN H |  |  |  | 10-027 | 10-064 | 11-051 | 12-018F |  |  |
| 121113010M |  | FY08 Final Dsgn Comptd for FPC | milestone | 0d | 2008-09-29 | 2008-09-29 | 9-080M, 121113005 | 249d | 141d |  |  | HOGAN J | 1 | 1 |  | 1.2.1.1.1.3 | JOHN H | 6 |  |  |  |  |  |  |  |  |
| 121113015 |  | Re-Baseline Actuals Adjustment |  | 1d | 2013-08-30 | 2013-08-30 | 9-130M FS+227d | 20d |  | PROCUREMENT>$50K 69 NO ESCALATION | 4,938.62 | HOGAN J | 1 | 1 |  |  | JOHN H |  | 13-014 | ADJ |  |  |  |  |  |  |
|  | 4 | **1.2.1.1.1.4 MISC. CAVITY STRING COMPONENTS** |  |  | 2009-03-04 | 2013-08-30 |  |  |  |  |  |  |  |  |  |  |  |  |  |  |  |  |  |  |  |  |
| 121114005 |  | Final Dsgn, Misc Cavity String Components |  | 140d | 2009-03-04 | 2009-09-18 | 121111010M, 9-090M FS+100d | 8d | 0d | MECH DES [40 h]; MECH ENG [40 h] | 4,306 | HOGAN J | 1 | 1 | 07-027 | 1.2.1.1.1.4 | JOHN H |  |  |  |  |  |  |  |  |  |
| 121114010M |  | FY09 Final Dsgn Comptd for Misc Cavity String Components | milestone | 0d | 2009-09-18 | 2009-09-18 | 121114005 | 8d | 0d |  |  | HOGAN J | 1 | 1 | 07-027 | 1.2.1.1.1.4 | JOHN H | 6 |  |  |  |  |  |  |  |  |
| 121114015 |  | Re-Baseline Actuals Adjustment |  | 1d | 2013-08-30 | 2013-08-30 | 9-130M FS+227d | 20d |  | PROCUREMENT>$50K 69 NO ESCALATION | 457.02 | HOGAN J | 1 | 1 |  |  | JOHN H |  | 13-014 | ADJ |  |  |  |  |  |  |
|  | 5 | **1.2.1.1.1.5 HOM/FIELD PROBES** |  |  | 2007-10-01 | 2013-08-30 |  |  |  |  |  |  |  |  |  |  |  |  |  |  |  |  |  |  |  |  |
| 121115005 |  | Final Dsgn HOM/Field Probes |  | 140d | 2007-10-01 | 2008-04-28 | 9-080M | 356d | 0d | MECH DES [80 h]; MECH ENG [40 h]; SR STAFF [40 h]; ELEC ENG [40 h]; SCIENTIST [40 h]; MECH TECH [80 h] | 17,974.8 | HOGAN J | 1 | 1 | 07-027 | 1.2.1.1.1.5 | JOHN H |  |  |  |  |  |  |  |  |  |
| 121115010M |  | FY08 Final Dsgn Comptd for HOM/Field Probes | milestone | 0d | 2008-04-28 | 2008-04-28 | 121115005 | 356d | 248d |  |  | HOGAN J | 1 | 1 | 07-027 | 1.2.1.1.1.5 | JOHN H | 6 |  |  |  |  |  |  |  |  |
| 121115015 |  | Re-Baseline Actuals Adjustment |  | 1d | 2013-08-30 | 2013-08-30 | 9-130M FS+227d | 20d |  | PROCUREMENT>$50K 69 NO ESCALATION | -17,975.04 | HOGAN J | 1 | 1 |  |  | JOHN H |  | 13-014 | ADJ |  |  |  |  |  |  |
|  | 6 | **1.2.1.1.1.6 HELIUM VESSELS** |  |  | 2007-08-15 | 2013-08-30 |  |  |  |  |  |  |  |  |  |  |  |  |  |  |  |  |  |  |  |  |
| 121116005 |  | Design Helium Headers Preliminary (HELIUM VESSLS) |  | 28d | 2007-08-15 | 2007-09-25 | 121124005, 121133005 | 97d | 0d | MECH DES [24.36 h]; MECH ENG [48.72 h] | 3,922.73 | HOGAN J | 1 | 1 | 07-027 | 1.2.1.1.1.6 | JOHN H |  |  |  |  |  |  |  | 2007-02-13 |  |
| 121116015 |  | Final Phase Final Dsgn, Helium Headers |  | 140d | 2008-10-01 | 2009-04-28 | 9-090M | 108d | 0d | MECH ENG [40 h]; MECH DES [40 h]; SUPPLIES & MATERIALS | 9,938.89 | HOGAN J | 1 | 1 | 07-027 | 1.2.1.1.1.6 | JOHN H |  |  |  |  |  |  |  |  | 09-012 |
| 121116010 |  | Design Helium Headers Initial Phase Final Design (HELIUM VESSLS) |  | 12d | 2008-11-26 | 2008-12-15 | 9-090M FS+40d, 121133010, 121124010 | 7d | 0d | MECH ENG [20.88 h]; MECH DES [10.44 h] | 1,790.04 | HOGAN J | 1 | 1 | 07-027 | 1.2.1.1.1.6 | JOHN H |  |  |  |  |  |  |  | 2007-06-26 |  |
| 121116020M |  | FY08 Final Dsgn Comptd for Helium Headers | milestone | 0d | 2009-04-28 | 2009-04-28 | 121116015 | 108d | 0d |  |  | HOGAN J | 1 | 1 | 07-027 | 1.2.1.1.1.6 | JOHN H | 6 |  |  |  |  |  |  |  |  |
| 121116025 |  | Re-Baseline Actuals Adjustment |  | 1d | 2013-08-30 | 2013-08-30 | 9-130M FS+227d | 20d |  | PROCUREMENT>$50K 69 NO ESCALATION | 37,471.45 | HOGAN J | 1 | 1 |  |  | JOHN H |  | 13-014 | ADJ |  |  |  |  |  |  |

| ID | WBS | Activity | Type | Duration | Start | Finish | Predecessors | Total float | Free float | Resources | Cost | RESP - Responsibility | STRT%COMP for CM EVM | FNSH%COMP for CM EVM | CR 07-027 | WBS ASSIGNMENT | CAM RESPONSIBLE | Milestone Level | CR 13-014 | ReBaseline Actuals Adjustment | CR 08-050 | CR 08-058 | CR 10-027 | CR 10-064 | CR 11-003 | CR 11-012 | CR 11-051 | CR 12-018 | Planned FinishUDF |
| --- | --- | --- | --- | --- | --- | --- | --- | --- | --- | --- | --- | --- | --- | --- | --- | --- | --- | --- | --- | --- | --- | --- | --- | --- | --- | --- | --- | --- | --- |
|  | 2 | **1.2.1.1.2 SPACE FRAME ASSEMBLY** |  |  | 2006-10-02 | 2013-08-30 |  |  |  |  |  |  |  |  |  |  |  |  |  |  |  |  |  |  |  |  |  |  |  |
|  | 1 | **1.2.1.1.2.1 TUNER ASSEMBLY** |  |  | 2009-03-13 | 2013-08-30 |  |  |  |  |  |  |  |  |  |  |  |  |  |  |  |  |  |  |  |  |  |  |  |
| 121121005 |  | Final Dsgn, Tuner |  | 140d | 2009-03-13 | 2009-09-29 | 9-090M FS+107d | 1d | 0d | MECH TECH [160 h]; SUPPLIES & MATERIALS; SR STAFF [40 h]; OFFICE [40 h]; MSHOP; MECH ENG [40 h]; MECH DES [80 h]; ELEC ENG [40 h] | 37,162.91 | HOGAN J | 1 | 1 | 07-027 | 1.2.1.1.2.1 | JOHN H |  |  |  |  |  |  |  |  |  |  |  |  |
| 121121010M |  | FY08 Final Dsgn Comptd for Tuner | milestone | 0d | 2009-09-29 | 2009-09-29 | 121121005 | 1d | 0d |  |  | HOGAN J | 1 | 1 | 07-027 | 1.2.1.1.2.1 | JOHN H | 6 |  |  |  |  |  |  |  |  |  |  |  |
| 121121015 |  | Re-Baseline Actuals Adjustment |  | 1d | 2013-08-30 | 2013-08-30 | 9-130M FS+227d | 20d |  | PROCUREMENT>$50K 69 NO ESCALATION | -36,964.7 | HOGAN J | 1 | 1 |  |  | JOHN H |  | 13-014 | ADJ |  |  |  |  |  |  |  |  |  |
|  | 2 | **1.2.1.1.2.2 HEADER ASSEMBLY, SUPPLY & RETURN** |  |  | 2008-10-01 | 2013-08-30 |  |  |  |  |  |  |  |  |  |  |  |  |  |  |  |  |  |  |  |  |  |  |  |
| 121122005 |  | Final Dsgn, Header Assy (Supply & Return) |  | 140d | 2008-10-01 | 2009-04-28 | 9-090M | 108d | 0d | MECH DES [80 h]; MECH ENG [40 h] | 6,059.6 | HOGAN J | 1 | 1 | 07-027 | 1.2.1.1.2.2 | JOHN H |  |  |  |  |  |  |  |  |  |  |  |  |
| 121122010M |  | FY08 Final Dsgn Comptd for Header Assy (Supply & Return) | milestone | 0d | 2009-04-28 | 2009-04-28 | 121122005 | 108d | 107d |  |  | HOGAN J | 1 | 1 | 07-027 | 1.2.1.1.2.2 | JOHN H | 6 |  |  |  |  |  |  |  |  |  |  |  |
| 121122015 |  | Re-Baseline Actuals Adjustment |  | 1d | 2013-08-30 | 2013-08-30 | 9-130M FS+227d | 20d |  | PROCUREMENT>$50K 69 NO ESCALATION | 446.79 | HOGAN J | 1 | 1 |  |  | JOHN H |  | 13-014 | ADJ |  |  |  |  |  |  |  |  |  |
|  | 3 | **1.2.1.1.2.3 MAGNETIC SHIELD ASSEMBLY** |  |  | 2008-10-01 | 2013-08-30 |  |  |  |  |  |  |  |  |  |  |  |  |  |  |  |  |  |  |  |  |  |  |  |
| 131133010XD |  | Prcrmnt Prep for Magnetic Shield |  | 59d | 2008-10-01 | 2008-12-24 | 9-090M | 101d | 0d | MECH ENG [13.56 h]; MECH DES [13.56 h] | 1,459.73 | HOGAN J | 1 | 1 |  |  | JOHN H |  |  |  | 08-050 | 08-058 | 10-027 | 10-064 | 11-003 | 11-012 | 11-051 | 12-018F |  |
| 121123005 |  | Final Dsgn, Magnetic Shield |  | 140d | 2009-01-05 | 2009-07-23 | 9-090M FS+60d | 48d | 0d | OFFICE [40 h]; MECH DES [80 h]; MECH ENG [40 h]; SUPPLIES & MATERIALS; SR STAFF [40 h] | 22,488.82 | HOGAN J | 1 | 1 | 07-027 | 1.2.1.1.2.3 | JOHN H |  |  |  |  |  |  |  |  |  |  |  |  |
| 121123010M |  | FY08 Final Dsgn Comptd for Magnetic Shield | milestone | 0d | 2009-07-23 | 2009-07-23 | 121123005 | 48d | 47d |  |  | HOGAN J | 1 | 1 | 07-027 | 1.2.1.1.2.3 | JOHN H | 6 |  |  |  |  |  |  |  |  |  |  |  |
| 121123015 |  | Re-Baseline Actuals Adjustment |  | 1d | 2013-08-30 | 2013-08-30 | 9-130M FS+227d | 20d |  | PROCUREMENT>$50K 69 NO ESCALATION | 11,262.88 | HOGAN J | 1 | 1 |  |  | JOHN H |  | 13-014 | ADJ |  |  |  |  |  |  |  |  |  |
|  | 4 | **1.2.1.1.2.4 THERMAL SHEILD ASSEMBLY, MLI BLANKETS 2&** |  |  | 2007-07-06 | 2013-08-30 |  |  |  |  |  |  |  |  |  |  |  |  |  |  |  |  |  |  |  |  |  |  |  |
| 121124005 |  | Design Thermal Shield Preliminary (THRML SHLD) |  | 28d | 2007-07-06 | 2007-08-15 | 121135005, 121131005 | 97d | 0d | MECH ENG [97.44 h]; MECH DES [48.72 h] | 7,845.45 | HOGAN J | 1 | 1 | 07-027 | 1.2.1.1.2.4 | JOHN H |  |  |  |  |  |  |  |  |  |  |  | 2007-01-03 |
| 121124010 |  | Design Thermal Shield Initial Phase Final Design (THRML SHLD) |  | 12d | 2008-07-03 | 2008-07-21 | 121131010, 121135010 | 97d | 0d | MECH DES [41.76 h]; MECH ENG [20.88 h] | 3,065.18 | HOGAN J | 1 | 1 |  | 1.2.1.1.2.4 | JOHN H |  |  |  |  |  |  |  |  |  |  |  | 2007-06-08 |
| 121124015 |  | Dsgn Thermal Shield, Final Phase Final Dsgn |  | 140d | 2008-10-01 | 2009-04-28 | 9-090M | 108d | 0d | MECH DES [80 h]; OFFICE [40 h]; MECH ENG [40 h] | 7,098.8 | HOGAN J | 1 | 1 | 07-027 | 1.2.1.1.2.4 | JOHN H |  |  |  |  |  |  |  |  |  |  |  |  |
| 121124020M |  | FY08 Final Dsgn Comptd for Thermal Shield | milestone | 0d | 2009-04-28 | 2009-04-28 | 121124015 | 108d | 107d |  |  | HOGAN J | 1 | 1 |  | 1.2.1.1.2.4 | JOHN H | 6 |  |  |  |  |  |  |  |  |  |  |  |
| 121124025 |  | Re-Baseline Actuals Adjustment |  | 1d | 2013-08-30 | 2013-08-30 | 9-130M FS+227d | 20d |  | PROCUREMENT>$50K 69 NO ESCALATION | 83,809.97 | HOGAN J | 1 | 1 |  |  | JOHN H |  | 13-014 | ADJ |  |  |  |  |  |  |  |  |  |
|  | 5 | **1.2.1.1.2.5 SEALS & MISC. SPACE FRAME COMPONENTS** |  |  | 2008-03-26 | 2013-08-30 |  |  |  |  |  |  |  |  |  |  |  |  |  |  |  |  |  |  |  |  |  |  |  |
| 121125005 |  | Design Seals & Misc Space Frame Preliminary (SEALS) |  | 28d | 2008-03-26 | 2008-05-05 | 121136005 FS+120d, 121116005 FS+120d, 121134005 FS+120d | 97d | 0d | MECH ENG [73.08 h]; MECH DES [24.36 h] | 5,554.08 | HOGAN J | 1 | 1 | 07-027 | 1.2.1.1.2.5 | JOHN H |  |  |  |  |  |  |  |  |  |  |  | 2007-03-26 |
| 121125010 |  | Design Seals & Misc Space Frame Initial Phase Final Design (SEALS) |  | 12d | 2008-12-16 | 2009-01-08 | 121136010, 121116010, 121134010 | 7d | 0d | MECH ENG [31.32 h]; MECH DES [10.44 h] | 2,456.22 | HOGAN J | 1 | 1 |  | 1.2.1.1.2.5 | JOHN H |  |  |  |  |  |  |  |  |  |  |  | 2007-07-13 |
| 121125015 |  | Final Phase Final Dsgn, Seals & Misc Space Frame |  | 140d | 2009-03-13 | 2009-09-29 | 9-090M FS+107d | 1d | 0d | MECH ENG [160 h]; MECH DES [160 h]; ELEC ENG [80 h]; MECH TECH [40 h] | 23,980.4 | HOGAN J | 1 | 1 | 07-027 | 1.2.1.1.2.5 | JOHN H |  |  |  |  |  |  |  |  |  |  |  |  |
| 121125020M |  | FY08 Final Dsgn Comptd for Seals & Misc Space Frame | milestone | 0d | 2009-09-29 | 2009-09-29 | 121125015 | 1d | 0d |  |  | HOGAN J | 1 | 1 | 07-027 | 1.2.1.1.2.5 | JOHN H | 6 |  |  |  |  |  |  |  |  |  |  |  |
| 121125025 |  | Re-Baseline Actuals Adjustment |  | 1d | 2013-08-30 | 2013-08-30 | 9-130M FS+227d | 20d |  | PROCUREMENT>$50K 69 NO ESCALATION | 10,008.03 | HOGAN J | 1 | 1 |  |  | JOHN H |  | 13-014 | ADJ |  |  |  |  |  |  |  |  |  |

Notes:
- 121121005: Corrective Actions: DDM: Added Machine Shop expense / resource ($5290) back into this activity.

| ID | WBS | Activity | Type | Duration | Start | Finish | Predecessors | Total float | Free float | Resources | Cost | Planned FinishUDF | RESP - Responsibility | STRT%COMP for CM EVM | FNSH%COMP for CM EVM | CR 07-027 | WBS ASSIGNMENT | CAM RESPONSIBLE | Milestone Level | CR 13-014 | ReBaseline Actuals Adjustment | CR 09-012 |
| --- | --- | --- | --- | --- | --- | --- | --- | --- | --- | --- | --- | --- | --- | --- | --- | --- | --- | --- | --- | --- | --- | --- |
|  | 6 | **1.2.1.1.2.6 SPACE FRAME** |  |  | 2006-10-02 | 2013-08-30 |  |  |  |  |  |  |  |  |  |  |  |  |  |  |  |  |
| 121126005 |  | Design Space Frame Preliminary (SPC FRM) |  | 184d | 2006-10-02 | 2007-06-29 | 9-070M | 97d | 0d | MECH DES [48.72 h]; MECH ENG [146.16 h] | 11,190.67 | 2006-11-08 | HOGAN J | 1 | 1 | 07-027 | 1.2.1.1.2.6 | JOHN H |  |  |  |  |
| 121126010 |  | Design Space Frame Initial Phase Final Design (SPC FRM) |  | 12d | 2008-06-13 | 2008-07-01 | 121138005 | 97d | 0d | MECH DES [20.88 h]; MECH ENG [62.64 h] | 4,760.64 | 2007-05-21 | HOGAN J | 1 | 1 | 07-027 | 1.2.1.1.2.6 | JOHN H |  |  |  |  |
| 121126015 |  | Final Phase Final Dsgn, Space Frame |  | 140d | 2009-02-03 | 2009-08-20 | 9-090M FS+80d | 28d | 0d | OFFICE [40 h]; MECH DES [240 h]; MECH ENG [160 h]; MECH TECH [40 h]; SR STAFF [40 h] | 27,502 |  | HOGAN J | 1 | 1 | 07-027 | 1.2.1.1.2.6 | JOHN H |  |  |  |  |
| 121126020M |  | FY08 Final Dsgn Comptd for Space Frame | milestone | 0d | 2009-08-20 | 2009-08-20 | 121126015 | 28d | 27d |  |  |  | HOGAN J | 1 | 1 |  | 1.2.1.1.2.6 | JOHN H | 6 |  |  |  |
| 121126025 |  | Re-Baseline Actuals Adjustment |  | 1d | 2013-08-30 | 2013-08-30 | 9-130M FS+227d | 20d |  | PROCUREMENT>$50K 69 NO ESCALATION | 18,260.82 |  | HOGAN J | 1 | 1 |  |  | JOHN H |  | 13-014 | ADJ |  |
|  | 3 | **1.2.1.1.3 CRYOMODULE ASSEMBLY** |  |  | 2006-10-02 | 2013-08-30 |  |  |  |  |  |  |  |  |  |  |  |  |  |  |  |  |
|  | 1 | **1.2.1.1.3.1 ALIGNMENT FIDUCIALS** |  |  | 2007-07-02 | 2013-08-30 |  |  |  |  |  |  |  |  |  |  |  |  |  |  |  |  |
| 121131005 |  | Design Alignment Fiducials Preliminary (ALGNMT FIDUCLS) |  | 3.5d | 2007-07-02 | 2007-07-06 | 121126005, 121132005 | 97d | 0d | MECH DES [24.36 h]; MECH ENG [24.36 h] | 2,462.83 | 2006-11-14 | HOGAN J | 1 | 1 | 07-027 | 1.2.1.1.3.1 | JOHN H |  |  |  |  |
| 121131010 |  | Design Alignment Fiducials Initial Phase Final Design (ALGNMT FIDUCLS) |  | 1.5d | 2008-07-01 | 2008-07-02 | 121126010, 121132010 | 97d | 0d | MECH ENG [10.44 h]; MECH DES [10.44 h] | 1,089.1 | 2007-05-22 | HOGAN J | 1 | 1 |  | 1.2.1.1.3.1 | JOHN H |  |  |  |  |
| 121131015 |  | Final Phase Final Dsgn, Alignment Fiducials |  | 140d | 2008-10-01 | 2009-04-28 | 9-090M | 83d | 0d | MECH DES [40 h]; MECH ENG [40 h] | 4,306 |  | HOGAN J | 1 | 1 | 07-027 | 1.2.1.1.3.1 | JOHN H |  |  |  | 09-012 |
| 121131020M |  | FY08 Final Dsgn Comptd for Alignment Fiducials | milestone | 0d | 2009-04-28 | 2009-04-28 | 121131015 | 83d | 107d |  |  |  | HOGAN J | 1 | 1 |  | 1.2.1.1.3.1 | JOHN H | 6 |  |  |  |
| 121131025 |  | Re-Baseline Actuals Adjustment |  | 1d | 2013-08-30 | 2013-08-30 | 9-130M FS+227d | 20d |  | PROCUREMENT>$50K 69 NO ESCALATION | -7,857.92 |  | HOGAN J | 1 | 1 |  |  | JOHN H |  | 13-014 | ADJ |  |
|  | 2 | **1.2.1.1.3.2 VACUUM TANK ASSEMBLY** |  |  | 2006-10-02 | 2013-08-30 |  |  |  |  |  |  |  |  |  |  |  |  |  |  |  |  |
| 121132005 |  | Design Vacuum Tank Preliminary (VAC TNK ASSMBLY) |  | 28d | 2006-10-02 | 2006-11-08 | 9-070M | 253d | 156d | MECH DES [48.72 h]; MECH ENG [146.16 h] | 11,186.6 | 2006-11-08 | HOGAN J | 1 | 1 |  | 1.2.1.1.3.2 | JOHN H |  |  |  |  |
| 121132010 |  | Design Vacuum Tank Initial Phase Final Design (VAC TNK ASSMBLY) |  | 12d | 2008-06-13 | 2008-07-01 | 121138005 | 97d | 0d | MECH ENG [62.64 h]; MECH DES [20.88 h] | 4,760.64 | 2007-05-21 | HOGAN J | 1 | 1 | 07-027 | 1.2.1.1.3.2 | JOHN H |  |  |  |  |
| 121132015 |  | Final Phase Final Dsgn, Vac Tank |  | 140d | 2009-03-13 | 2009-09-29 | 9-090M FS+107d | -24d | 0d | MECH DES [160 h]; SR STAFF [40 h]; MECH TECH [40 h]; OFFICE [40 h]; MECH ENG [120 h] | 21,442.4 |  | HOGAN J | 1 | 1 | 07-027 | 1.2.1.1.3.2 | JOHN H |  |  |  |  |
| 121132020M |  | FY08 Final Dsgn Comptd for Vac Tank | milestone | 0d | 2009-09-29 | 2009-09-29 | 121132015 | -24d | 0d |  |  |  | HOGAN J | 1 | 1 |  | 1.2.1.1.3.2 | JOHN H | 6 |  |  |  |
| 121132025 |  | Re-Baseline Actuals Adjustment |  | 1d | 2013-08-30 | 2013-08-30 | 9-130M FS+227d | 20d |  | PROCUREMENT>$50K 69 NO ESCALATION | -1,702.58 |  | HOGAN J | 1 | 1 |  |  | JOHN H |  | 13-014 | ADJ |  |
|  | 3 | **1.2.1.1.3.3 END CAN ASSEMBLY** |  |  | 2007-07-06 | 2013-08-30 |  |  |  |  |  |  |  |  |  |  |  |  |  |  |  |  |
| 121133005 |  | Design End Cans Preliminary (END CAN ASSMBLY) |  | 28d | 2007-07-06 | 2007-08-15 | 121131005, 121135005 | 97d | 0d | MECH DES [48.72 h]; MECH ENG [146.16 h] | 10,765.25 | 2007-01-03 | HOGAN J | 1 | 1 | 07-027 | 1.2.1.1.3.3 | JOHN H |  |  |  |  |
| 121133010 |  | Design End Cans Initial Phase Final Design (END CAN ASSMBLY) |  | 12d | 2008-07-03 | 2008-07-21 | 121135010, 121131010 | 97d | 0d | MECH DES [20.88 h]; MECH ENG [62.64 h] | 4,760.64 | 2007-06-08 | HOGAN J | 1 | 1 |  | 1.2.1.1.3.3 | JOHN H |  |  |  |  |
| 121133015 |  | Final Phase Final Dsgn, End Cans |  | 140d | 2008-10-01 | 2009-04-28 | 9-090M | 83d | 0d | ELEC ENG [40 h]; OFFICE [40 h]; MECH ENG [80 h]; MECH DES [160 h]; SR STAFF [40 h] | 19,841.2 |  | HOGAN J | 1 | 1 | 07-027 | 1.2.1.1.3.3 | JOHN H |  |  |  |  |
| 121133020M |  | FY08 Final Dsgn Comptd for End Cans | milestone | 0d | 2009-04-28 | 2009-04-28 | 121133015 | 83d | 107d |  |  |  | HOGAN J | 1 | 1 |  | 1.2.1.1.3.3 | JOHN H | 6 |  |  |  |
| 121133025 |  | Re-Baseline Actuals Adjustment |  | 1d | 2013-08-30 | 2013-08-30 | 9-130M FS+227d | 20d |  | PROCUREMENT>$50K 69 NO ESCALATION | 13,565.51 |  | HOGAN J | 1 | 1 |  |  | JOHN H |  | 13-014 | ADJ |  |

| ID | WBS | Activity | Type | Duration | Start | Finish | Predecessors | Total float | Free float | Resources | Cost | Planned FinishUDF | RESP - Responsibility | STRT%COMP for CM EVM | FNSH%COMP for CM EVM | WBS ASSIGNMENT | CAM RESPONSIBLE | CR 07-027 | Milestone Level | CR 13-014 | ReBaseline Actuals Adjustment |
| --- | --- | --- | --- | --- | --- | --- | --- | --- | --- | --- | --- | --- | --- | --- | --- | --- | --- | --- | --- | --- | --- |
|  | 4 | **1.2.1.1.3.4 BEAM LINE ASSEMBLY WITHIN CM** |  |  | 2007-08-15 | 2013-08-30 |  |  |  |  |  |  |  |  |  |  |  |  |  |  |  |
| 121134005 |  | Design Transition Beamline Preliminary (BEAMLINE ASSMBLY) |  | 28d | 2007-08-15 | 2007-09-25 | 121133005, 121124005 | 97d | 0d | MECH DES [48.72 h]; MECH ENG [73.08 h] | 6,385.55 | 2007-02-13 | HOGAN J | 1 | 1 | 1.2.1.1.3.4 | JOHN H |  |  |  |  |
| 121134010 |  | Design Transition Beamline Initial Phase Final Design (BEAMLINE ASSMBLY) |  | 12d | 2008-07-22 | 2008-08-06 | 121133010, 121124010 | 97d | 90d | MECH ENG [31.32 h]; MECH DES [20.88 h] | 2,823.81 | 2007-06-26 | HOGAN J | 1 | 1 | 1.2.1.1.3.4 | JOHN H |  |  |  |  |
| 121134015 |  | Final Phase Final Dsgn, Transition BL in CM |  | 140d | 2009-03-13 | 2009-09-29 | 9-090M FS+107d | -24d | 0d | SUPPLIES & MATERIALS; MECH ENG [80 h]; MECH DES [120 h]; ELEC ENG [80 h]; MECH TECH [80 h] | 30,016.42 |  | HOGAN J | 1 | 1 | 1.2.1.1.3.4 | JOHN H | 07-027 |  |  |  |
| 121134020M |  | FY08 Final Dsgn Comptd for Transition BL in CM | milestone | 0d | 2009-09-29 | 2009-09-29 | 121134015 | -24d | 0d |  |  |  | HOGAN J | 1 | 1 | 1.2.1.1.3.4 | JOHN H |  | 6 |  |  |
| 121134025 |  | Re-Baseline Actuals Adjustment |  | 1d | 2013-08-30 | 2013-08-30 | 9-130M FS+227d | 20d |  | PROCUREMENT>$50K 69 NO ESCALATION | 39,223.87 |  | HOGAN J | 1 | 1 |  | JOHN H |  |  | 13-014 | ADJ |
|  | 5 | **1.2.1.1.3.5 STANDS** |  |  | 2007-07-02 | 2013-08-30 |  |  |  |  |  |  |  |  |  |  |  |  |  |  |  |
| 121135005 |  | Design Stands Preliminary (STANDS) |  | 0.7d | 2007-07-02 | 2007-07-02 | 121126005, 121132005 | 99.8d | 2.8d | MECH ENG [24.36 h]; MECH DES [24.36 h] | 2,462.83 | 2006-11-09 | HOGAN J | 1 | 1 | 1.2.1.1.3.5 | JOHN H |  |  |  |  |
| 121135010 |  | Design Stands Initial Phase Final Design (STANDS) |  | 0.3d | 2008-07-01 | 2008-07-01 | 121126010, 121132010 | 98.2d | 1.2d | MECH DES [10.44 h]; MECH ENG [10.44 h] | 1,089.1 | 2007-05-21 | HOGAN J | 1 | 1 | 1.2.1.1.3.5 | JOHN H |  |  |  |  |
| 121135015 |  | Final Phase Final Dsgn, Stands |  | 140d | 2009-03-11 | 2009-09-25 | 9-090M FS+105d | -22d | 0d | MECH ENG [40 h]; MECH DES [40 h] | 4,306 |  | HOGAN J | 1 | 1 | 1.2.1.1.3.5 | JOHN H | 07-027 |  |  |  |
| 121135020M |  | FY08 Final Dsgn Comptd for Stands | milestone | 0d | 2009-09-25 | 2009-09-25 | 121135015 | -22d | 2d |  |  |  | HOGAN J | 1 | 1 | 1.2.1.1.3.5 | JOHN H |  | 6 |  |  |
| 121135025 |  | Re-Baseline Actuals Adjustment |  | 1d | 2013-08-30 | 2013-08-30 | 9-130M FS+227d | 20d |  | PROCUREMENT>$50K 69 NO ESCALATION | -7,857.91 |  | HOGAN J | 1 | 1 |  | JOHN H |  |  | 13-014 | ADJ |
|  | 6 | **1.2.1.1.3.6 WIRING INCL HOM & FP CABLES** |  |  | 2007-08-15 | 2013-08-30 |  |  |  |  |  |  |  |  |  |  |  |  |  |  |  |
| 121136005 |  | Design Wiring Preliminary (WIRING) |  | 28d | 2007-08-15 | 2007-09-25 | 121133005, 121124005 | 97d | 0d | MECH DES [24.36 h]; MECH ENG [48.72 h] | 3,922.73 | 2007-02-13 | HOGAN J | 1 | 1 | 1.2.1.1.3.6 | JOHN H | 07-027 |  |  |  |
| 121136010 |  | Design Wiring Initial Phase Final Design (WIRING) |  | 12d | 2008-07-22 | 2008-08-06 | 121133010, 121124010 | 97d | 90d | MECH ENG [20.88 h]; MECH DES [10.44 h] | 1,734.71 | 2007-06-26 | HOGAN J | 1 | 1 | 1.2.1.1.3.6 | JOHN H |  |  |  |  |
| 121136015 |  | Final Phase Final Dsgn, Wiring |  | 140d | 2009-03-13 | 2009-09-29 | 9-090M FS+107d | -24d | 0d | ELEC DES [120 h]; MECH DES [160 h]; MECH ENG [40 h]; ELEC ENG [80 h]; SUPPLIES & MATERIALS | 25,855.69 |  | HOGAN J | 1 | 1 | 1.2.1.1.3.6 | JOHN H | 07-027 |  |  |  |
| 121136020M |  | FY08 Final Dsgn Comptd for Wiring | milestone | 0d | 2009-09-29 | 2009-09-29 | 121136015 | -24d | 0d |  |  |  | HOGAN J | 1 | 1 | 1.2.1.1.3.6 | JOHN H |  | 6 |  |  |
| 121136025 |  | Re-Baseline Actuals Adjustment |  | 1d | 2013-08-30 | 2013-08-30 | 9-130M FS+227d | 20d |  | PROCUREMENT>$50K 69 NO ESCALATION | -29,255.43 |  | HOGAN J | 1 | 1 |  | JOHN H |  |  | 13-014 | ADJ |
|  | 7 | **1.2.1.1.3.7 FEEDTHROUGHS INCL WARM/COLD HOM/FP** |  |  | 2008-03-26 | 2013-08-30 |  |  |  |  |  |  |  |  |  |  |  |  |  |  |  |
| 121137005 |  | Design Feedthroughs Preliminary (FEEDTHRU) |  | 28d | 2008-03-26 | 2008-05-05 | 121136005 FS+120d, 121134005 FS+120d, 121116005 FS+120d | 97d | 0d | MECH ENG [48.72 h]; MECH DES [24.36 h] | 4,047.65 | 2007-03-26 | HOGAN J | 1 | 1 | 1.2.1.1.3.7 | JOHN H | 07-027 |  |  |  |
| 121137015 |  | Final Phase Final Dsgn, Feedthroughs |  | 140d | 2008-10-01 | 2009-04-28 | 9-090M | 83d | 0d | ELEC TECH [40 h]; MECH ENG [120 h]; MECH DES [320 h]; MECH TECH [160 h]; SUPPLIES & MATERIALS; ELEC ENG [40 h] | 54,886.84 |  | HOGAN J | 1 | 1 | 1.2.1.1.3.7 | JOHN H | 07-027 |  |  |  |
| 121137010 |  | Design Feedthroughs Initial Phase Final Design (FEEDTHRU) |  | 12d | 2008-12-16 | 2009-01-08 | 121136010, 121116010, 121134010 | 7d | 0d | MECH ENG [20.88 h]; MECH DES [10.44 h] | 1,790.04 | 2007-07-13 | HOGAN J | 1 | 1 | 1.2.1.1.3.7 | JOHN H |  |  |  |  |
| 121137020M |  | FY08 Final Dsgn Comptd for Feedthroughs | milestone | 0d | 2009-04-28 | 2009-04-28 | 121137015 | 83d | 107d |  |  |  | HOGAN J | 1 | 1 | 1.2.1.1.3.7 | JOHN H |  | 6 |  |  |
| 121137025 |  | Re-Baseline Actuals Adjustment |  | 1d | 2013-08-30 | 2013-08-30 | 9-130M FS+227d | 20d |  | PROCUREMENT>$50K 69 NO ESCALATION | 6,586.39 |  | HOGAN J | 1 | 1 |  | JOHN H |  |  | 13-014 | ADJ |

| ID | WBS | Activity | Type | Duration | Start | Finish | Predecessors | Total float | Free float | Resources | Cost | Planned FinishUDF | RESP - Responsibility | STRT%COMP for CM EVM | FNSH%COMP for CM EVM | WBS ASSIGNMENT | CAM RESPONSIBLE | CR 07-027 | CR 09-012 | CR 09-016 | Milestone Level | CR 13-014 | ReBaseline Actuals Adjustment | Profile change |
| --- | --- | --- | --- | --- | --- | --- | --- | --- | --- | --- | --- | --- | --- | --- | --- | --- | --- | --- | --- | --- | --- | --- | --- | --- |
|  | 8 | **1.2.1.1.3.8 HOM LOADS** |  |  | 2008-05-05 | 2013-08-30 |  |  |  |  |  |  |  |  |  |  |  |  |  |  |  |  |  |  |
| 121138005 |  | Design HOM Loads Preliminary (HOM LOADS) |  | 28d | 2008-05-05 | 2008-06-13 | 121125005, 121137005 | 97d | 0d | MECH DES [24.36 h]; MECH ENG [24.36 h] | 2,541.23 | 2007-05-03 | HOGAN J | 1 | 1 | 1.2.1.1.3.8 | JOHN H |  |  |  |  |  |  |  |
| 121138010 |  | Design HOM Loads Initial Phase Final Design (HOM LOADS) |  | 12d | 2009-01-09 | 2009-01-27 | 121137010, 121125010 | 7d | 31d | MECH DES [10.44 h]; MECH ENG [10.44 h] | 1,123.87 | 2007-07-31 | HOGAN J | 1 | 1 | 1.2.1.1.3.8 | JOHN H |  |  |  |  |  |  |  |
| 121138015 |  | Final Phase Final Dsgn, HOM Loads |  | 140d | 2009-03-13 | 2009-09-29 | 121138010, 9-090M FS+107d | -24d | 0d | SUPPLIES & MATERIALS; MECH ENG [160 h]; MECH DES [160 h]; MECH TECH [160 h]; ELEC ENG [80 h]; SR STAFF [40 h]; SCIENTIST [80 h] | 60,641.64 |  | HOGAN J | 1 | 1 | 1.2.1.1.3.8 | JOHN H | 07-027 | 09-012 |  |  |  |  |  |
| 121138025 |  | Computational Analysis |  | 5d | 2009-03-16 | 2009-03-23 | 11114070M FS+165d | 74.5d | 0d | SCIENTIST [40 h] | 2,570.4 |  | HOGAN J | 1 | 1 | 1.2.1.1.3.8 | JOHN H |  |  | 09-016 |  |  |  |  |
| 121138030 |  | Fabricate Test Hardware |  | 10d | 2009-03-23 | 2009-04-06 | 121138025 | 74.5d | 0d | MECH DES [40 h]; MECH TECH [80 h]; SUPPLIES & MATERIALS; MECH ENG [40 h] | 11,542 |  | HOGAN J | 1 | 1 | 1.2.1.1.3.8 | JOHN H |  |  | 09-016 |  |  |  |  |
| 121138035 |  | Measure (First) HOM Damping in VTA |  | 10d | 2009-04-06 | 2009-04-20 | 121138030 | 74.5d | 0d | COMP SCIENT [40 h]; SCIENTIST [80 h]; ELEC TECH [120 h]; MECH TECH [120 h]; ELEC ENG [80 h] | 22,342 |  | HOGAN J | 1 | 1 | 1.2.1.1.3.8 | JOHN H |  |  | 09-016 |  |  |  |  |
| 121138040 |  | Evaluate (First) Measurement results |  | 5d | 2009-04-20 | 2009-04-27 | 121138035 | 74.5d | 0d | SCIENTIST [80 h]; SR STAFF [40 h]; ELEC ENG [40 h] | 11,823.6 |  | HOGAN J | 1 | 1 | 1.2.1.1.3.8 | JOHN H |  |  | 09-016 |  |  |  |  |
| 121138045 |  | Modify Test Hardware |  | 10d | 2009-04-27 | 2009-05-11 | 121138040 | 74.5d | 0d | MECH DES [40 h]; SUPPLIES & MATERIALS; MECH TECH [80 h]; MECH ENG [40 h] | 10,542 |  | HOGAN J | 1 | 1 | 1.2.1.1.3.8 | JOHN H |  |  | 09-016 |  |  |  |  |
| 121138050 |  | Measure (Second) HOM Damping in VTA |  | 10d | 2009-05-11 | 2009-05-26 | 121138045 | 74.5d | 0d | ELEC TECH [120 h]; MECH TECH [120 h]; COMP SCIENT [40 h]; SCIENTIST [80 h]; ELEC ENG [80 h] | 22,342 |  | HOGAN J | 1 | 1 | 1.2.1.1.3.8 | JOHN H |  |  | 09-016 |  |  |  |  |
| 121138055 |  | Evaluate (Second) Measurement results |  | 5d | 2009-05-26 | 2009-06-02 | 121138050 | 74.5d | 0d | SR STAFF [40 h]; ELEC ENG [40 h] | 6,682.8 |  | HOGAN J | 1 | 1 | 1.2.1.1.3.8 | JOHN H |  |  | 09-016 |  |  |  |  |
| 121138060 |  | Document HOM damping results and final |  | 10d | 2009-06-02 | 2009-06-16 | 121138055 | 74.5d |  | SCIENTIST [40 h] | 2,570.4 |  | HOGAN J | 1 | 1 | 1.2.1.1.3.8 | JOHN H |  |  | 09-016 |  |  |  |  |
| 121138020M |  | FY08 Final Dsgn Comptd for HOM Loads | milestone | 0d | 2009-09-29 | 2009-09-29 | 121138015 | -24d | 0d |  |  |  | HOGAN J | 1 | 1 | 1.2.1.1.3.8 | JOHN H |  |  |  | 6 |  |  |  |
| 121138065 |  | Re-Baseline Actuals Adjustment |  | 1d | 2013-08-30 | 2013-08-30 | 9-130M FS+227d | 20d |  | PROCUREMENT>$50K 69 NO ESCALATION | -92,544.23 |  | HOGAN J | 1 | 1 |  | JOHN H |  |  |  |  | 13-014 | ADJ |  |
|  | 4 | **1.2.1.1.4 INSTALLATION & ASSEMBLY TOOLING** |  |  | 2008-10-01 | 2013-08-30 |  |  |  |  |  |  |  |  |  |  |  |  |  |  |  |  |  |  |
| 12114000 |  | Final Dsgn of Installtn & Assy Tooling |  | 140d | 2008-10-01 | 2009-04-28 | 9-090M | 108d | 0d | MECH DES [320 h]; MECH ENG [160 h]; SUPPLIES & MATERIALS; MECH TECH [80 h] | 50,027.24 |  | HOGAN J | 1 | 1 | 1.2.1.1.4 | JOHN H | 07-027 | 09-012 |  |  |  |  |  |
| 12114005M |  | FY08 Final Dsgn Comptd for Installtn & Assy Tooling | milestone | 0d | 2009-04-28 | 2009-04-28 | 12114000 | 108d | 107d |  |  |  | HOGAN J | 1 | 1 | 1.2.1.1.4 | JOHN H | 07-027 |  |  | 6 |  |  |  |
| 12114010 |  | Re-Baseline Actuals Adjustment |  | 1d | 2013-08-30 | 2013-08-30 | 9-130M FS+227d | 20d |  | PROCUREMENT>$50K 69 NO ESCALATION | -19,123.75 |  | HOGAN J | 1 | 1 |  | JOHN H |  |  |  |  | 13-014 | ADJ |  |
|  | 5 | **1.2.1.1.5 CRYOMODULE TEST INSTRUMENTATION & INTERLOCKS** |  |  | 2009-03-13 | 2013-08-30 |  |  |  |  |  |  |  |  |  |  |  |  |  |  |  |  |  |  |
| 12115000 |  | Final Dsgn of Instrmenttn & Interlocks |  | 140d | 2009-03-13 | 2009-09-29 | 9-090M FS+107d | 1d | 0d | MECH DES [40 h]; MECH TECH [80 h]; SUPPLIES & MATERIALS; ELEC ENG [160 h]; ELEC DES [160 h]; ELEC TECH [80 h] | 37,113.22 |  | HOGAN J | 1 | 1 | 1.2.1.1.5 | JOHN H | 07-027 |  |  |  |  |  |  |
| 12115005M |  | FY08 Final Dsgn Comptd for Instrmenttn & Interlocks | milestone | 0d | 2009-09-29 | 2009-09-29 | 12115000 | 1d | 0d |  |  |  | HOGAN J | 1 | 1 | 1.2.1.1.5 | JOHN H |  |  |  | 6 |  |  |  |
| 12115010 |  | Re-Baseline Actuals Adjustment |  | 1d | 2013-08-30 | 2013-08-30 | 9-130M FS+227d | 20d |  | PROCUREMENT>$50K 69 NO ESCALATION | -10,715.98 |  | HOGAN J | 1 | 1 |  | JOHN H |  |  |  |  | 13-014 | ADJ |  |
|  | 2 | **1.2.1.2 POWER SYSTEMS** |  |  | 2006-10-02 | 2013-08-30 |  |  |  |  |  |  |  |  |  |  |  |  |  |  |  |  |  |  |
|  | 1 | **1.2.1.2.1 RF** |  |  | 2006-10-02 | 2013-08-30 |  |  |  |  |  |  |  |  |  |  |  |  |  |  |  |  |  |  |
|  | 1 | **1.2.1.2.1.1 POWER** |  |  | 2006-10-02 | 2013-08-30 |  |  |  |  |  |  |  |  |  |  |  |  |  |  |  |  |  |  |
|  | 1 | **1.2.1.2.1.1.1 KLYSTRONS** |  |  | 2006-10-02 | 2013-08-30 |  |  |  |  |  |  |  |  |  |  |  |  |  |  |  |  |  |  |
| 1212111000M |  | Start Klystron PED effort (KLYSTRONS) | milestone | 0d | 2006-10-02 | 2006-10-02 | 9-070M | 0d |  |  |  | 2006-10-02 | NELSON R | 1 | 1 | 1.2.1.2.1.1.1 | BILL M |  |  |  | 6 |  |  |  |
| 1212111007LOE |  | FY07 Project administration (KLYSTRONS) |  | 247d | 2006-10-02 | 2007-09-28 | 1212111000M | 0d |  | SR STAFF [382.8 h] | 38,132.05 | 2007-09-28 | NELSON R | 1 | 1 | 1.2.1.2.1.1.1 | BILL M |  | 09-012 |  |  |  |  |  |
| 1212111010 |  | Refine klystron specifications w/driver (KLYSTRONS) |  | 100d | 2006-10-02 | 2007-03-02 | 1212111000M | 8d | 0d | ELEC ENG [52.2 h]; ELEC DES [69.6 h] | 6,579.46 | 2007-03-02 | NELSON R | 1 | 1 | 1.2.1.2.1.1.1 | BILL M |  |  |  |  |  |  |  |
| 1212111015M |  | Specifications revision complete (KLYSTRONS) | milestone | 0d | 2007-03-02 | 2007-03-02 | 1212111010 | 8d | 0d |  |  | 2007-03-02 | NELSON R | 1 | 1 | 1.2.1.2.1.1.1 | BILL M |  |  |  | 6 |  |  |  |
| 1212111030 |  | Internal design & safety review of klystron specifications (KLYSTRONS) |  | 10d | 2007-03-05 | 2007-03-16 | 1212111015M | 8d | 0d | TRAVEL; ELEC ENG [17.4 h] | 3,213.62 | 2007-03-16 | NELSON R | 1 | 1 | 1.2.1.2.1.1.1 | BILL M |  |  |  |  |  |  |  |
| 1212111035M |  | Preliminary internal design & safety review complete (KLYSTRONS) | milestone | 0d | 2007-03-16 | 2007-03-16 | 1212111030 | 8d | 0d |  |  | 2007-03-16 | NELSON R | 1 | 1 | 1.2.1.2.1.1.1 | BILL M |  |  |  | 6 |  |  |  |
| 1212111040 |  | Revise preliminary klystron specifications per design & safety review (KLYSTRONS) |  | 20d | 2007-03-19 | 2007-04-13 | 1212111035M | 8d | 0d | ELEC ENG [6.96 h] | 446.1 | 2007-04-13 | NELSON R | 1 | 1 | 1.2.1.2.1.1.1 | BILL M |  |  |  |  |  |  |  |
| 1212111020 |  | Update budgetary pricing through vendor requests (KLYSTRONS) |  | 20d | 2007-04-16 | 2007-05-11 | 1212111015M, 1212111040, 1212111035M | 8d | 0d | ELEC ENG [10.44 h]; TRAVEL | 4,774.53 | 2007-05-11 | NELSON R | 1 | 1 | 1.2.1.2.1.1.1 | BILL M |  |  |  |  |  |  |  |
| 1212111025M |  | Budgetary pricing received from vendors (KLYSTRONS) | milestone | 0d | 2007-05-11 | 2007-05-11 | 1212111020 | 8d | 0d |  |  | 2007-05-11 | NELSON R | 1 | 1 | 1.2.1.2.1.1.1 | BILL M |  |  |  | 6 |  |  |  |
| 1212111045 |  | Revise costbook based on new pricing (KLYSTRONS) |  | 5d | 2007-05-14 | 2007-05-18 | 1212111025M | 8d | 0d | ELEC ENG [17.4 h] | 1,080.89 | 2007-05-18 | NELSON R | 1 | 1 | 1.2.1.2.1.1.1 | BILL M |  |  |  |  |  |  |  |
| 1212111050M |  | Klystron preliminary design complete (KLYSTRONS) | milestone | 0d | 2007-05-18 | 2007-05-18 | 1212111040, 1212111045 | 8d | 0d |  |  | 2007-05-18 | NELSON R | 1 | 1 | 1.2.1.2.1.1.1 | BILL M |  |  |  | 5 |  |  |  |
| 1212111055 |  | Begin final design (FY07 continuing into FY08) (KLYSTRONS) |  | 92d | 2007-05-21 | 2007-09-28 | 1212111050M | 8d | 0d | ELEC ENG [34.8 h] | 2,118.78 | 2007-09-28 | NELSON R | 1 | 1 | 1.2.1.2.1.1.1 | BILL M |  |  |  |  |  |  |  |
| 1212111070 |  | Develop Final Klystron Spec's (Klystrons) |  | 60d | 2007-10-01 | 2008-01-03 | 1212111055, 9-080M | 8d | 0d | ELEC TECH [80 h]; TRAVEL; ELEC DES [44 h] | 7,200.31 |  | NELSON R | 1 | 1 | 1.2.1.2.1.1.1 | BILL M |  |  |  |  |  |  |  |
| 1212111908LOE |  | FY08 Proj Admin (Klystrons) |  | 248d | 2007-10-01 | 2008-09-30 | 9-080M, 1212111007LOE | 0d |  | SR STAFF [1040 h] | 103,646.4 |  | NELSON R | 1 | 1 | 1.2.1.2.1.1.1 | BILL M |  |  |  |  |  |  |  |
| 1212111075 |  | Write Final Rquirmnts/Prcrmnt Packages (Klystrons) |  | 60d | 2008-01-04 | 2008-03-31 | 1212111070 | 8d | 0d | ELEC ENG [48 h]; SUPPLIES & MATERIALS | 5,649.82 |  | NELSON R | 1 | 1 | 1.2.1.2.1.1.1 | BILL M |  |  |  |  |  |  |  |
| 1212111080M |  | Comp klystron PED 2008 (KLYSTRONS) | milestone | 0d | 2008-03-31 | 2008-03-31 | 1212111075 | 81d | 0d |  |  |  | NELSON R | 1 | 1 | 1.2.1.2.1.1.1 | BILL M |  |  |  | 6 |  |  |  |
| 1212111085 |  | Release Prcrmnt Package for Klystron Solicitation (Klystrons) |  | 40d | 2008-04-01 | 2008-05-27 | 1212111075 | 8d | 0d | ELEC DES [40 h]; ELEC ENG [8 h]; SUPPLIES & MATERIALS | 4,942.22 |  | NELSON R | 1 | 1 | 1.2.1.2.1.1.1 | BILL M |  |  |  |  |  |  |  |
| 1212111170 |  | Pre-Constrctn Dsgn Review (Klystrons) |  | 5d | 2008-04-01 | 2008-04-07 | 1212111080M | 81d |  |  |  |  | NELSON R | 1 | 1 | 1.2.1.2.1.1.1 | BILL M |  |  |  |  |  |  | C |
| 1212111100 |  | Eng-Receive & Evaluate Klystron Proposals (Klystrons) |  | 10d | 2008-05-28 | 2008-06-10 | 1212111085 | 8d | 0d | ELEC ENG [20 h] | 1,244.8 |  | NELSON R | 1 | 1 | 1.2.1.2.1.1.1 | BILL M |  |  |  |  |  |  |  |
| 1212111110 |  | Des-Receive & Evaluate Klystron Proposals (Klystrons) |  | 10d | 2008-06-11 | 2008-06-24 | 1212111100 | 8d | 0d | ELEC DES [40 h] | 1,782 |  | NELSON R | 1 | 1 | 1.2.1.2.1.1.1 | BILL M |  |  |  |  |  |  |  |
| 1212111115 |  | Release Best & Final for Klystrons (Klystrons) |  | 20d | 2008-08-07 | 2008-09-04 | 1212111110 FS+30d | 8d | 0d | ELEC ENG [20 h] | 1,244.8 |  | NELSON R | 1 | 1 | 1.2.1.2.1.1.1 | BILL M |  |  |  |  |  |  |  |
| 1212111120 |  | Final Klystron Evaluation (Klystrons)+ |  | 10d | 2008-09-05 | 2008-09-18 | 1212111115 | 8d |  | ELEC ENG [20 h] | 1,244.8 |  | NELSON R | 1 | 1 | 1.2.1.2.1.1.1 | BILL M | 07-027 |  |  |  |  |  |  |
| 1212111175 |  | Re-Baseline Actuals Adjustment |  | 1d | 2013-08-30 | 2013-08-30 | 9-130M FS+227d | 20d |  | PROCUREMENT>$50K 69 NO ESCALATION | -1,967.82 |  | NELSON R | 1 | 1 |  | BILL M |  |  |  |  | 13-014 | ADJ |  |

| ID | WBS | Activity | Type | Duration | Start | Finish | Predecessors | Total float | Free float | Resources | Cost | Planned FinishUDF | RESP - Responsibility | STRT%COMP for CM EVM | FNSH%COMP for CM EVM | Milestone Level | WBS ASSIGNMENT | CAM RESPONSIBLE | CR 07-027 | CR 07-024 | CR 08-016 | Duplications | EXPNS ACT BRIDGING FY SPLIT | CR 09-012 | CR 13-014 | ReBaseline Actuals Adjustment |
| --- | --- | --- | --- | --- | --- | --- | --- | --- | --- | --- | --- | --- | --- | --- | --- | --- | --- | --- | --- | --- | --- | --- | --- | --- | --- | --- |
|  | 2 | **1.2.1.2.1.1.2 DC POWER** |  |  | 2006-10-02 | 2013-08-30 |  |  |  |  |  |  |  |  |  |  |  |  |  |  |  |  |  |  |  |  |
| 1212112000M |  | FY07 Begin DC Power PED efforts (DC POWER) | milestone | 0d | 2006-10-02 | 2006-10-02 | 9-070M | 160d | 0d |  |  | 2006-10-02 | NELSON R | 1 | 1 | 6 | 1.2.1.2.1.1.2 | BILL M |  |  |  |  |  |  |  |  |
| 1212112005 |  | Develop preliminary requirements for klystron HVPS (DC POWER) |  | 15d | 2006-10-02 | 2006-10-20 | 1212112000M | 160d | 0d | ELEC ENG [34.8 h] | 2,299.24 | 2006-10-20 | NELSON R | 1 | 1 |  | 1.2.1.2.1.1.2 | BILL M |  |  |  |  |  |  |  |  |
| 1212112010M |  | Preliminary HVPS requirements document complete (DC POWER) | milestone | 0d | 2006-10-20 | 2006-10-20 | 1212112005 | 160d | 0d |  |  | 2006-10-20 | NELSON R | 1 | 1 | 6 | 1.2.1.2.1.1.2 | BILL M |  |  |  |  |  |  |  |  |
| 1212112015 |  | Develop aux power supply requirements preliminary designs (includes rack configuration) (DC POWER) |  | 80d | 2006-10-23 | 2007-02-23 | 1212112010M | 548d | 0d | ELEC DES [34.8 h]; ELEC ENG [208.8 h]; OFFICE [34.8 h] | 16,257.86 | 2007-02-23 | NELSON R | 1 | 1 |  | 1.2.1.2.1.1.2 | BILL M |  |  |  |  |  |  |  |  |
| 1212112025 |  | Conduct internal design & safety review (DC POWER) |  | 10d | 2006-10-30 | 2006-11-10 | 1212112010M FS+5d | 160d | 0d | ELEC ENG [34.8 h]; OFFICE [34.8 h] | 3,196.38 | 2007-03-09 | NELSON R | 1 | 1 |  | 1.2.1.2.1.1.2 | BILL M |  |  |  |  |  |  |  |  |
| 1212112030M |  | Internal design & safety review complete (DC POWER) | milestone | 0d | 2006-11-10 | 2006-11-10 | 1212112025, 1212112010M | 160d | 0d |  |  | 2007-03-09 | NELSON R | 1 | 1 | 5 | 1.2.1.2.1.1.2 | BILL M |  |  |  |  |  |  |  |  |
| 1212112035 |  | Revise requirements based on review outcome (DC POWER) |  | 10d | 2006-11-13 | 2006-11-28 | 1212112030M, 1212112025 | 160d | 0d | ELEC ENG [52.2 h] | 3,448.85 | 2007-03-23 | NELSON R | 1 | 1 |  | 1.2.1.2.1.1.2 | BILL M |  |  |  |  |  |  |  |  |
| 1212112040M |  | Requirements revised (DC POWER) | milestone | 0d | 2006-11-28 | 2006-11-28 | 1212112035 | 160d | 0d |  |  | 2007-03-23 | NELSON R | 1 | 1 | 6 | 1.2.1.2.1.1.2 | BILL M |  |  |  |  |  |  |  |  |
| 1212112045 |  | Request budgetary pricing for HVPS (DC POWER) |  | 20d | 2006-11-29 | 2007-01-03 | 1212112035, 1212112040M | 160d | 0d | ELEC ENG [17.4 h] | 1,149.62 | 2007-04-20 | NELSON R | 1 | 1 |  | 1.2.1.2.1.1.2 | BILL M |  |  |  |  |  |  |  |  |
| 1212112065 |  | Build & test preliminary designs (fil/mod anode) (DC POWER) |  | 40d | 2006-12-20 | 2007-02-23 | 1212112060M FS-20d | 160d | 0d | SUPPLIES & MATERIALS; ELEC ENG [229.68 h]; ELEC TECH [417.6 h] | 35,566.95 | 2007-08-21 | NELSON R | 1 | 1 |  | 1.2.1.2.1.1.2 | BILL M |  |  |  |  |  |  |  |  |
| 1212112050M |  | Budgetary pricing received (DC POWER) | milestone | 0d | 2007-01-03 | 2007-01-03 | 1212112045 | 160d | 0d |  |  | 2007-04-20 | NELSON R | 1 | 1 | 6 | 1.2.1.2.1.1.2 | BILL M |  |  |  |  |  |  |  |  |
| 1212112080 |  | Update costbook (DC POWER) |  | 5d | 2007-01-04 | 2007-01-10 | 1212112050M | 160d | 0d | ELEC ENG [34.8 h] | 2,299.24 | 2007-04-27 | NELSON R | 1 | 1 |  | 1.2.1.2.1.1.2 | BILL M |  |  |  |  |  |  |  |  |
| 1212112085M |  | Costbook pricing updated (DC POWER) | milestone | 0d | 2007-01-10 | 2007-01-10 | 1212112080 | 160d | 0d |  |  | 2007-04-27 | NELSON R | 1 | 1 | 6 | 1.2.1.2.1.1.2 | BILL M |  |  |  |  |  |  |  |  |
| 1212112055 |  | Procure components for preliminary design tests (DC POWER) |  | 10d | 2007-01-11 | 2007-01-25 | 1212112085M | 160d | 0d | PROCUREMENT<$50K 60; OFFICE [34.8 h]; ELEC ENG [17.4 h] | 25,786.76 | 2007-05-11 | NELSON R | 1 | 1 |  | 1.2.1.2.1.1.2 | BILL M |  |  |  |  |  |  |  |  |
| 1212112060M |  | Components received for preliminary design tests (DC POWER) | milestone | 0d | 2007-01-25 | 2007-01-25 | 1212112055 | 160d | 0d |  |  | 2007-05-11 | NELSON R | 1 | 1 | 6 | 1.2.1.2.1.1.2 | BILL M |  |  |  |  |  |  |  |  |
| 1212112020 |  | Develop preliminary layout/packaging designs (DC POWER) |  | 100d | 2007-02-26 | 2007-07-17 | 1212112010M, 1212112015 | 548d |  | ELEC DES [104.4 h]; SUPPLIES & MATERIALS; ELEC ENG [52.2 h] | 11,054.06 | 2007-07-17 | NELSON R | 1 | 1 |  | 1.2.1.2.1.1.2 | BILL M |  |  |  |  |  |  |  |  |
| 1212112070 |  | Revise preliminary designs (DC POWER) |  | 10d | 2007-02-26 | 2007-03-09 | 1212112060M, 1212112040M, 1212112065 | 160d | 0d | ELEC ENG [69.6 h]; ELEC DES [34.8 h] | 6,163.77 | 2007-09-28 | NELSON R | 1 | 1 |  | 1.2.1.2.1.1.2 | BILL M |  |  |  |  |  |  |  |  |
| 1212112075M |  | Preliminary designs revised (DC POWER) | milestone | 0d | 2007-03-09 | 2007-03-09 | 1212112070 | 160d | 142d |  |  | 2007-09-28 | NELSON R | 1 | 1 | 5 | 1.2.1.2.1.1.2 | BILL M |  |  |  |  |  |  |  |  |
| 1212112090M |  | FY08 Begin DC Pwr PED (DC POWER) | milestone | 0d | 2007-10-01 | 2007-10-01 | 9-080M, 1212112075M | 18d | 0d |  |  |  | NELSON R | 1 | 1 | 6 | 1.2.1.2.1.1.2 | BILL M | 07-027 |  |  |  |  |  |  |  |
| 1212112908LOE |  | FY08 Office Supprt for Document Prep (DC POWER) |  | 248d | 2007-10-01 | 2008-09-30 | 1212111007LOE, 9-080M | 0d |  | OFFICE [240 h]; SUPPLIES & MATERIALS | 9,510.38 |  | NELSON R | 1 | 1 |  | 1.2.1.2.1.1.2 | BILL M |  |  |  |  |  |  |  |  |
| 1212112100 |  | Dsgn & Test filament Pwr Supply (DC POWER) |  | 60d | 2008-04-01 | 2008-06-24 | 1212112090M FS+120d | 131d | 0d | ELEC TECH [560 h]; PROCUREMENT<$50K 60; ELEC ENG [360 h]; ELEC DES [120 h] | 58,840.3 |  | NELSON R | 1 | 1 |  | 1.2.1.2.1.1.2 | BILL M |  | 07-024 |  |  |  |  |  |  |
| 1212112110 |  | Dsgn & Test Mods anode Pwr Supply (DC POWER) |  | 60d | 2008-05-28 | 2008-08-20 | 1212112105 FS-40d | 143d | 0d | ELEC DES [120 h]; ELEC TECH [480 h]; PROCUREMENT<$50K 60; ELEC ENG [480 h] | 63,194.7 |  | NELSON R | 1 | 1 |  | 1.2.1.2.1.1.2 | BILL M |  |  |  |  |  |  |  |  |
| 1212112105 |  | Prep Documentation for Fab:/Prcrmnt filament (DC POWER) |  | 20d | 2008-06-25 | 2008-07-23 | 1212112100 | 143d | 0d | ELEC DES [80 h] | 3,564 |  | NELSON R | 1 | 1 |  | 1.2.1.2.1.1.2 | BILL M |  |  |  |  |  |  |  |  |
| 1212112130 |  | PROC Dsgn HPA/Rack Sys & Inj. Upgrade(DC POWER) |  | 145d | 2008-06-25 | 2009-01-28 | 1212112100 | 131d | 0d | PROCUREMENT<$50K 60 NO ESCALATION FY09 | 12,382.8 |  | NELSON R | 1 | 1 |  | 1.2.1.2.1.1.2 | BILL M |  | 07-024 | 08-016 | DUP | EXP0809 | 09-012 |  |  |
| 1212112130a |  | FY08 LAB/EXP Dsgn HPA/Rack Sys & Inj. Upgrade(DC POWER) |  | 68d | 2008-06-25 | 2008-09-30 | 1212112100 | 131d | 0d | ELEC TECH [150.07 h]; MECH DES [225.1 h]; SUPPLIES & MATERIALS; ELEC DES [93.79 h]; ELEC ENG [281.38 h] | 39,094.52 |  | NELSON R | 1 | 1 |  | 1.2.1.2.1.1.2 | BILL M |  | 07-024 | 08-016 | DUP | EXP0809 |  |  |  |
| 1212112115 |  | FY08 Prep Documentation for Fab/Prcrmnt: Mods anode (DC POWER) |  | 28d | 2008-08-21 | 2008-09-30 | 1212112110 | 143d | 0d | ELEC DES [112 h] | 4,989.6 |  | NELSON R | 1 | 1 |  | 1.2.1.2.1.1.2 | BILL M |  |  |  |  | EXP0809 |  |  |  |
| 1212112120 |  | PROC Dsgn & Test Ion Pump Pwr Supply (DC POWER) |  | 78d | 2008-09-12 | 2009-01-09 | 1212112115a FS-15d | 143d | 0d | PROCUREMENT<$50K 60 NO ESCALATION FY09 | 6,191.4 |  | NELSON R | 1 | 1 |  | 1.2.1.2.1.1.2 | BILL M |  |  | 08-016 |  | EXP0809 | 09-012 |  |  |
| 1212112120a |  | FY08 LAB Dsgn & Test Ion Pump Pwr Supply (DC POWER) |  | 13d | 2008-09-12 | 2008-09-30 | 1212112115a FS-15d | 143d | 0d | ELEC DES [20 h]; ELEC TECH [80 h]; ELEC ENG [80 h] | 8,984.6 |  | NELSON R | 1 | 1 |  | 1.2.1.2.1.1.2 | BILL M |  |  | 08-016 |  | EXP0809 |  |  |  |
| 1212112115a |  | FY09 Prep Documentation for Fab/Prcrmnt: Mods anode (DC POWER) |  | 2d | 2008-10-01 | 2008-10-02 | 1212112115 | 143d | 0d | ELEC DES [8 h] | 367.84 |  | NELSON R | 1 | 1 |  | 1.2.1.2.1.1.2 | BILL M |  |  |  |  | EXP0809 |  |  |  |
| 1212112120b |  | FY09 LAB Dsgn & Test Ion Pump Pwr Supply (DC POWER) |  | 65d | 2008-10-01 | 2009-01-09 | 1212112120a | 143d | 0d | ELEC TECH [400 h]; ELEC ENG [400 h]; ELEC DES [100 h] | 46,358 |  | NELSON R | 1 | 1 |  | 1.2.1.2.1.1.2 | BILL M |  |  | 08-016 |  | EXP0809 |  |  |  |
| 1212112130b |  | FY09 LAB/EXP Dsgn HPA/Rack Sys & Inj. Upgrade(DC POWER) |  | 77d | 2008-10-01 | 2009-01-28 | 1212112130a | 131d | 0d | SUPPLIES & MATERIALS; MECH DES [254.9 h]; ELEC DES [106.21 h]; ELEC ENG [318.62 h]; ELEC TECH [169.93 h] | 45,684.73 |  | NELSON R | 1 | 1 |  | 1.2.1.2.1.1.2 | BILL M |  | 07-024 | 08-016 | DUP | EXP0809 |  |  |  |
| 1212112125 |  | Prep Documentation for Fab/Prcrmnt; ION (DC POWER) |  | 20d | 2009-01-12 | 2009-02-09 | 1212112120, 1212112120b | 143d | 12d | ELEC DES [80 h] | 3,678.4 |  | NELSON R | 1 | 1 |  | 1.2.1.2.1.1.2 | BILL M |  |  |  |  |  |  |  |  |
| 1212112135 |  | Prep Documentation for Fab/Prcrmnt (DC POWER) |  | 20d | 2009-01-29 | 2009-02-26 | 1212112130, 1212112130b | 131d | 0d | ELEC ENG [160 h]; ELEC DES [160 h] | 17,633.6 |  | NELSON R | 1 | 1 |  | 1.2.1.2.1.1.2 | BILL M |  |  |  |  |  | 09-012 |  |  |
| 1212112140 |  | Prep Final Rquirmnts Package for HV PS Prcrmnt (DC POWER) |  | 20d | 2009-02-27 | 2009-03-26 | 1212112135, 1212112125 | 131d | 0d | ELEC ENG [120 h]; TRAVEL; ELEC DES [40 h] | 12,847.73 |  | NELSON R | 1 | 1 |  | 1.2.1.2.1.1.2 | BILL M |  |  |  |  |  |  |  |  |
| 1212112145M |  | Finish 2008 DC Pwr PED (DC POWER)+ | milestone | 0d | 2009-03-26 | 2009-03-26 | 1212112140 | 131d |  |  |  |  | NELSON R | 1 | 1 | 6 | 1.2.1.2.1.1.2 | BILL M | 07-027 |  |  |  |  |  |  |  |
| 1212112150 |  | Re-Baseline Actuals Adjustment |  | 1d | 2013-08-30 | 2013-08-30 | 9-130M FS+227d | 20d |  | PROCUREMENT>$50K 69 NO ESCALATION | -61,159.81 |  | NELSON R | 1 | 1 |  |  | BILL M |  |  |  |  |  |  | 13-014 | ADJ |

Notes:
- 1212112090M: Entry Criteria: Ext Pred: / 1212112075M
- 1212112100: Entry Criteria: Ext Pred: klystron sufficiently / defined to define needs
- 1212112140: Entry Criteria: Ext Pred: klystron sufficiently / defined to define needs

| ID | WBS | Activity | Type | Duration | Start | Finish | Predecessors | Total float | Free float | Resources | Cost | Planned FinishUDF | RESP - Responsibility | STRT%COMP for CM EVM | FNSH%COMP for CM EVM | Milestone Level | WBS ASSIGNMENT | CAM RESPONSIBLE | CR 07-027 | CR 09-012 | EXPNS ACT BRIDGING FY SPLIT | CR 13-014 | ReBaseline Actuals Adjustment | CR 08-009 | CR 08-016 |
| --- | --- | --- | --- | --- | --- | --- | --- | --- | --- | --- | --- | --- | --- | --- | --- | --- | --- | --- | --- | --- | --- | --- | --- | --- | --- |
|  | 3 | **1.2.1.2.1.1.3 WAVEGUIDE COMPONENTS** |  |  | 2006-10-02 | 2013-08-30 |  |  |  |  |  |  |  |  |  |  |  |  |  |  |  |  |  |  |  |
| 1212113000M |  | Begin waveguide PED effort (WVGUIDE COMPON) | milestone | 0d | 2006-10-02 | 2006-10-02 | 9-070M | 429d | 0d |  |  | 2006-10-02 | NELSON R | 1 | 1 | 6 | 1.2.1.2.1.1.3 | BILL M |  |  |  |  |  |  |  |
| 1212113005 |  | Develop preliminary waveguide requirements and layout (WVGUIDE COMPON) |  | 120d | 2006-10-02 | 2007-03-30 | 1212113000M | 429d | 0d | ELEC TECH [69.6 h]; ELEC ENG [52.2 h]; ELEC DES [69.6 h] | 9,462.29 | 2007-03-30 | NELSON R | 1 | 1 |  | 1.2.1.2.1.1.3 | BILL M |  |  |  |  |  |  |  |
| 1212113010 |  | Conduct internal design & safety review (WVGUIDE COMPON) |  | 10d | 2007-04-02 | 2007-04-13 | 1212113005, 1212113000M | 429d | 0d | OFFICE [34.8 h]; ELEC ENG [17.4 h] | 1,976.64 | 2007-04-13 | NELSON R | 1 | 1 |  | 1.2.1.2.1.1.3 | BILL M |  |  |  |  |  |  |  |
| 1212113015M |  | Design & safety review complete (WVGUIDE COMPON) | milestone | 0d | 2007-04-13 | 2007-04-13 | 1212113005, 1212113000M, 1212113010 | 429d | 0d |  |  | 2007-04-13 | NELSON R | 1 | 1 | 4 | 1.2.1.2.1.1.3 | BILL M |  |  |  |  |  |  |  |
| 1212113020 |  | Revise preliminary designs (WVGUIDE COMPON) |  | 5d | 2007-04-16 | 2007-04-20 | 1212113015M | 429d | 0d | ELEC ENG [17.4 h] | 1,080.89 | 2007-04-20 | NELSON R | 1 | 1 |  | 1.2.1.2.1.1.3 | BILL M |  |  |  |  |  |  |  |
| 1212113025M |  | Requirements revised (WVGUIDE COMPON) | milestone | 0d | 2007-04-20 | 2007-04-20 | 1212113020 | 429d | 0d |  |  | 2007-04-20 | NELSON R | 1 | 1 | 6 | 1.2.1.2.1.1.3 | BILL M |  |  |  |  |  |  |  |
| 1212113030 |  | Request budgetary pricing for waveguide components (WVGUIDE COMPON) |  | 20d | 2007-04-23 | 2007-05-18 | 1212113025M | 429d | 0d | ELEC ENG [17.4 h] | 1,080.89 | 2007-05-18 | NELSON R | 1 | 1 |  | 1.2.1.2.1.1.3 | BILL M |  |  |  |  |  |  |  |
| 1212113035M |  | Receive budgetary pricing (WVGUIDE COMPON) | milestone | 0d | 2007-05-18 | 2007-05-18 | 1212113030 | 429d | 0d |  |  | 2007-05-18 | NELSON R | 1 | 1 | 6 | 1.2.1.2.1.1.3 | BILL M |  |  |  |  |  |  |  |
| 1212113040 |  | Revise costbook pricing (WVGUIDE COMPON) |  | 5d | 2007-05-21 | 2007-05-25 | 1212113035M | 429d | 0d | ELEC ENG [17.4 h] | 1,080.89 | 2007-05-25 | NELSON R | 1 | 1 |  | 1.2.1.2.1.1.3 | BILL M |  |  |  |  |  |  |  |
| 1212113045M |  | Costbook revised (WVGUIDE COMPON) | milestone | 0d | 2007-05-25 | 2007-05-25 | 1212113040 | 429d | 0d |  |  | 2007-05-25 | NELSON R | 1 | 1 | 6 | 1.2.1.2.1.1.3 | BILL M |  |  |  |  |  |  |  |
| 1212113050M |  | Begin final design (WVGUIDE COMPON) | milestone | 0d | 2007-05-29 | 2007-05-29 | 1212113045M | 429d | 0d |  |  | 2007-05-28 | NELSON R | 1 | 1 | 6 | 1.2.1.2.1.1.3 | BILL M |  |  |  |  |  |  |  |
| 1212113055 |  | Final design FY07 Phase (WVGUIDE COMPON) |  | 59d | 2007-05-29 | 2007-08-20 | 1212113050M | 429d | 208d | ELEC TECH [69.6 h] | 2,668.9 | 2007-09-28 | NELSON R | 1 | 1 |  | 1.2.1.2.1.1.3 | BILL M | 07-027 |  |  |  |  |  |  |
| 1212113060M |  | Begin 2008 Waveguide Systems PED (WVGUIDE COMPON) | milestone | 0d | 2008-06-25 | 2008-06-25 | 9-080M FS+180d, 1212113055 | 221d | 0d |  |  |  | NELSON R | 1 | 1 | 6 | 1.2.1.2.1.1.3 | BILL M | 07-027 |  |  |  |  |  |  |
| 1212113065 |  | Office Admin Supprt (WVGUIDE COMPON) |  | 65d | 2008-06-25 | 2008-09-25 | 1212113060M | 246d | 25d | OFFICE [80 h] | 2,014.4 |  | NELSON R | 1 | 1 |  | 1.2.1.2.1.1.3 | BILL M |  |  |  |  |  |  |  |
| 1212113070 |  | Develop Rquirmnts Package for circulator (WVGUIDE COMPON) |  | 30d | 2008-06-25 | 2008-08-06 | 1212113060M | 221d | 0d | ELEC DES [20 h]; ELEC TECH [40 h]; ELEC ENG [80 h]; SUPPLIES & MATERIALS | 10,894.58 |  | NELSON R | 1 | 1 |  | 1.2.1.2.1.1.3 | BILL M |  |  |  |  |  |  |  |
| 1212113075 |  | Develop Rquirmnts Package for HOM Filter (WVGUIDE COMPON) |  | 0d | 2008-08-14 | 2008-08-14 | 1212113070 FS+5d | 221d | 0d |  |  |  | NELSON R | 1 | 1 |  | 1.2.1.2.1.1.3 | BILL M | 07-027 | 09-012 |  |  |  |  |  |
| 1212113080 |  | FY08 LAB/EXPDevelop Rquirmnts Packages for Custom Waveguide pcs (WVGUIDE COMPON) |  | 33d | 2008-08-14 | 2008-09-30 | 1212113075 | 221d | 0d | SUPPLIES & MATERIALS; ELEC ENG [105.6 h]; ELEC TECH [52.8 h]; MECH DES [105.6 h]; ELEC DES [52.8 h] | 18,278.92 |  | NELSON R | 1 | 1 |  | 1.2.1.2.1.1.3 | BILL M |  |  | EXP0809 |  |  |  |  |
| 1212113080a |  | FY09 LAB/EXP Develop Rquirmnts Packages for Custom Waveguide pcs (WVGUIDE COMPON) |  | 17d | 2008-10-01 | 2008-10-23 | 1212113080 | 221d | 0d | ELEC DES [27.2 h]; ELEC ENG [54.4 h]; ELEC TECH [27.2 h]; MECH DES [54.4 h]; SUPPLIES & MATERIALS | 9,717.5 |  | NELSON R | 1 | 1 |  | 1.2.1.2.1.1.3 | BILL M |  |  | EXP0809 |  |  |  |  |
| 1212113085 |  | Revise Vend Pricing for Waveguide Compnts (WVGUIDE COMPON) |  | 5d | 2008-10-24 | 2008-10-30 | 1212113080a | 221d | 0d | ELEC ENG [40 h] | 2,569.2 |  | NELSON R | 1 | 1 |  | 1.2.1.2.1.1.3 | BILL M |  |  |  |  |  |  |  |
| 1212113090M |  | Waveguide PED Comp 2008 (WVGUIDE COMPON)++ | milestone | 0d | 2008-10-30 | 2008-10-30 | 1212113065, 1212113085 | 221d | 0d |  |  |  | NELSON R | 1 | 1 | 6 | 1.2.1.2.1.1.3 | BILL M |  |  |  |  |  |  |  |
| 1212113170 |  | Pre-Constrctn Dsgn Review (WVGUIDE COMPON)+ |  | 5d | 2008-10-31 | 2008-11-06 | 1212113090M | 221d | 191d |  |  |  | NELSON R | 1 | 1 |  | 1.2.1.2.1.1.3 | BILL M | 07-027 |  |  |  |  |  |  |
| 1212113175 |  | Re-Baseline Actuals Adjustment |  | 1d | 2013-08-30 | 2013-08-30 | 9-130M FS+227d | 20d |  | PROCUREMENT>$50K 69 NO ESCALATION | -20,415.45 |  | NELSON R | 1 | 1 |  |  | BILL M |  |  |  | 13-014 | ADJ |  |  |
|  | 2 | **1.2.1.2.1.2 CONTROL** |  |  | 2006-10-02 | 2013-08-30 |  |  |  |  |  |  |  |  |  |  |  |  |  |  |  |  |  |  |  |
|  | 1 | **1.2.1.2.1.2.1 FIELD CONTROL (RF/DSP)** |  |  | 2006-10-02 | 2013-08-30 |  |  |  |  |  |  |  |  |  |  |  |  |  |  |  |  |  |  |  |
| 1212121030M |  | Begin Preliminary Digital Board Design (FLD CNTL) | milestone | 0d | 2006-10-02 | 2006-10-02 | 9-070M | 34d | 0d |  |  | 2006-10-02 | HOVATER C | 1 | 1 | 6 | 1.2.1.2.1.2.1 | BILL M |  |  |  |  |  |  |  |
| 1212121035 |  | Develop Detailed Specification (FLD CNTL) |  | 20d | 2006-10-02 | 2006-10-27 | 1212121030M | 34d | 0d | ELEC ENG [34.8 h] | 2,299.24 | 2006-10-27 | HOVATER C | 1 | 1 |  | 1.2.1.2.1.2.1 | BILL M |  |  |  |  |  |  |  |
| 1212121060M |  | Start Preliminary RF Board design (FLD CNTL) | milestone | 0d | 2006-10-02 | 2006-10-02 | 9-070M | 14d | 0d |  |  | 2006-10-02 | HOVATER C | 1 | 1 | 6 | 1.2.1.2.1.2.1 | BILL M |  |  |  |  |  |  |  |
| 1212121065 |  | Develop RF Board Detailed specification (FLD CNTL) |  | 20d | 2006-10-02 | 2006-10-27 | 1212121060M | 14d | 0d | ELEC ENG [34.8 h] | 2,299.24 | 2006-10-27 | HOVATER C | 1 | 1 |  | 1.2.1.2.1.2.1 | BILL M |  |  |  |  |  |  |  |
| 1212121125 |  | Prepare for EIR (FLD CNTL) |  | 58d | 2006-10-02 | 2006-12-22 |  | 158d | 0d | ELEC ENG [34.8 h]; ELEC TECH [34.8 h] | 3,740.66 | 2007-05-01 | HOVATER C | 1 | 1 |  | 1.2.1.2.1.2.1 | BILL M |  |  |  |  |  |  |  |
| 1212121040 |  | Develop Preliminary Design Digital Board (FLD CNTL) |  | 60d | 2006-10-30 | 2007-02-01 | 1212121035 | 34d | 0d | ELEC TECH [69.6 h]; ELEC ENG [278.4 h]; ELEC DES [243.6 h] | 32,233.85 | 2007-02-01 | HOVATER C | 1 | 1 |  | 1.2.1.2.1.2.1 | BILL M |  |  |  |  |  |  |  |
| 1212121070 |  | Preliminary RF Board Design Complete (FLD CNTL) |  | 40d | 2006-10-30 | 2007-01-03 | 1212121065 | 14d | 0d | ELEC ENG [174 h]; ELEC DES [243.6 h]; ELEC TECH [69.6 h] | 25,336.14 | 2007-01-03 | HOVATER C | 1 | 1 |  | 1.2.1.2.1.2.1 | BILL M |  |  |  |  |  |  |  |
| 1212121000M |  | Preliminary Integrated LLRF System Design (FLD CNTL) | milestone | 0d | 2006-12-05 | 2006-12-05 | 9-070M FS+44d | 131.5d | 0d |  |  | 2006-12-05 | HOVATER C | 1 | 1 | 6 | 1.2.1.2.1.2.1 | BILL M |  |  |  |  |  |  |  |
| 1212121005 |  | Develop Preliminary System Design (FLD CNTL) |  | 80d | 2006-12-05 | 2007-04-05 | 1212121000M | 591d | 80d | SCIENTIST [69.6 h]; COMP SCIENT [34.8 h]; ELEC ENG [208.8 h] | 20,235.49 | 2007-04-05 | HOVATER C | 1 | 1 |  | 1.2.1.2.1.2.1 | BILL M |  |  |  |  |  |  |  |
| 1212121015 |  | Update LLRF Model (FLD CNTL) |  | 60d | 2006-12-05 | 2007-03-08 | 1212121000M | 131.5d | 25d | SCIENTIST [156.6 h]; ELEC ENG [17.4 h] | 11,201.77 | 2007-05-01 | HOVATER C | 1 | 1 |  | 1.2.1.2.1.2.1 | BILL M |  |  |  |  |  |  |  |
| 1212121130M |  | Field Control Ready for Baseline (FLD CNTL) | milestone | 0d | 2006-12-22 | 2006-12-22 | 1212121125 | 158d |  |  |  | 2007-05-01 | HOVATER C | 1 | 1 | 5 | 1.2.1.2.1.2.1 | BILL M |  |  |  |  |  |  |  |
| 1212121075 |  | Procure RF Board validation unit (FLD CNTL) |  | 4d | 2007-01-04 | 2007-01-09 | 1212121070 | 14d | 0d | PROCUREMENT<$50K 60 | 6,190 | 2007-01-09 | HOVATER C | 1 | 1 |  | 1.2.1.2.1.2.1 | BILL M |  |  |  |  |  |  |  |
| 1212121010 |  | Investigate Comparitive System Designs (FLD CNTL) |  | 60d | 2007-01-10 | 2007-04-05 | 1212121000M FS+20d | 591d | 80d | SCIENTIST [34.8 h]; TRAVEL; ELEC ENG [104.4 h] | 24,582.52 | 2007-04-05 | HOVATER C | 1 | 1 |  | 1.2.1.2.1.2.1 | BILL M |  |  |  |  |  |  |  |
| 1212121045 |  | Procure Digital Board validation unit (FLD CNTL) |  | 4d | 2007-02-02 | 2007-02-07 | 1212121040 | 34d | 0d | PROCUREMENT<$50K 60 | 6,190 | 2007-02-07 | HOVATER C | 1 | 1 |  | 1.2.1.2.1.2.1 | BILL M |  |  |  |  |  |  |  |
| 1212121050 |  | Conduct Digital Board Validation Tests (FLD CNTL) |  | 40d | 2007-02-08 | 2007-04-05 | 1212121045 | 34d | 0d | ELEC ENG [174 h]; ELEC DES [34.8 h]; COMP SCIENT [34.8 h]; ELEC TECH [69.6 h] | 17,876.76 | 2007-04-05 | HOVATER C | 1 | 1 |  | 1.2.1.2.1.2.1 | BILL M |  |  |  |  |  |  |  |
| 1212121110M |  | Start Cost & Schedule Update (FLD CNTL) | milestone | 0d | 2007-02-08 | 2007-02-08 | 1212121045, 1212121075 | 106.5d | 0d |  |  | 2007-02-08 | HOVATER C | 1 | 1 | 5 | 1.2.1.2.1.2.1 | BILL M |  |  |  |  |  |  |  |
| 1212121115 |  | Update PED Cost and Schedule (FLD CNTL) |  | 45d | 2007-02-08 | 2007-04-12 | 1212121110M | 106.5d | 0d | ELEC ENG [34.8 h] | 2,271.74 | 2007-04-12 | HOVATER C | 1 | 1 |  | 1.2.1.2.1.2.1 | BILL M |  |  |  |  |  |  |  |
| 1212121120 |  | Update Construction Cost and Schedule (FLD CNTL) |  | 30d | 2007-02-08 | 2007-03-22 | 1212121110M | 124d | 17.5d | ELEC TECH [17.2 h]; ELEC ENG [34.8 h] | 3,011.66 | 2007-03-22 | HOVATER C | 1 | 1 |  | 1.2.1.2.1.2.1 | BILL M |  |  |  |  |  |  |  |
| 1212121080 |  | Conduct RF Board Validation tests (FLD CNTL) |  | 40d | 2007-03-09 | 2007-05-03 | 1212121075 FS+40d | 14d | 0d | ELEC DES [34.8 h]; ELEC ENG [174 h]; ELEC TECH [70 h] | 15,457.36 | 2007-03-08 | HOVATER C | 1 | 1 |  | 1.2.1.2.1.2.1 | BILL M |  |  |  |  |  |  |  |
| 1212121055M |  | Digital Board Validation Tests complete (FLD CNTL) | milestone | 0d | 2007-04-05 | 2007-04-05 | 1212121050 | 167d | 0d |  |  | 2007-04-05 | HOVATER C | 1 | 1 | 5 | 1.2.1.2.1.2.1 | BILL M |  |  |  |  |  |  |  |
| 1212121020 |  | Develop Preliminary Design (FLD CNTL) |  | 2.5d | 2007-04-13 | 2007-04-17 | 1212121115, 1212121015 | 106.5d | 0d | ELEC ENG [17.4 h] | 1,080.89 | 2007-05-03 | HOVATER C | 1 | 1 |  | 1.2.1.2.1.2.1 | BILL M |  |  |  |  |  |  |  |
| 1212121020M |  | Preliminary Design Complete (FLD CNTL) | milestone | 0d | 2007-04-17 | 2007-04-17 | 1212121020 | 106.5d | 0d |  |  | 2007-05-03 | HOVATER C | 1 | 1 | 5 | 1.2.1.2.1.2.1 | BILL M |  |  |  |  |  |  |  |
| 1212121025 |  | Conduct Preliminary Design & Safety Review 1.2.1.2.1.2 LLRF (FLD CNTL) |  | 20d | 2007-04-17 | 2007-05-15 | 1212121120, 1212121020M, 1212121020 | 106.5d | 92.5d | OFFICE [34.8 h]; COMP SCIENT [34.8 h]; SCIENTIST [34.8 h]; ELEC ENG [139.2 h]; TRAVEL | 18,936.27 | 2007-06-01 | HOVATER C | 1 | 1 |  | 1.2.1.2.1.2.1 | BILL M |  |  |  |  |  |  |  |
| 1212121085M |  | RF Board Validation Tests complete (FLD CNTL) | milestone | 0d | 2007-05-03 | 2007-05-03 | 1212121080 | 14d | 0d |  |  | 2007-03-08 | HOVATER C | 1 | 1 | 5 | 1.2.1.2.1.2.1 | BILL M |  |  |  |  |  |  |  |
| 1212121100 |  | Conduct Field Control System Validation (FLD CNTL) |  | 100d | 2007-05-04 | 2007-09-25 | 1212121085M, 1212121050 | 14d | 0d | ELEC ENG [139.2 h]; PROCUREMENT<$50K 60 | 13,656.42 | 2007-08-08 | HOVATER C | 1 | 1 |  | 1.2.1.2.1.2.1 | BILL M |  |  |  |  |  |  |  |
| 1212121090M |  | Start Field Control System Test (FLD CNTL) | milestone | 0d | 2007-07-31 | 2007-07-31 | 1212121005, 1212121010, 1212121055M FS+80d | 511d | 0d |  |  | 2007-04-06 | HOVATER C | 1 | 1 | 6 | 1.2.1.2.1.2.1 | BILL M | 07-027 |  |  |  |  |  |  |
| 1212121095 |  | Modify Field Control Firmware (FLD CNTL) |  | 28d | 2007-07-31 | 2007-09-07 | 1212121090M | 511d |  | COMP SCIENT [34.8 h]; PROCUREMENT<$50K 60; ELEC ENG [139.2 h] | 15,507.44 | 2007-06-29 | HOVATER C | 1 | 1 |  | 1.2.1.2.1.2.1 | BILL M |  |  |  |  |  |  |  |
| 1212121105M |  | Field Control System validation complete (FLD CNTL) | milestone | 0d | 2007-09-25 | 2007-09-25 | 1212121100, 1212121025 | 14d | 3d |  |  | 2007-08-08 | HOVATER C | 1 | 1 | 5 | 1.2.1.2.1.2.1 | BILL M |  |  |  |  |  |  |  |
| 1212121135 |  | Validation Testing on Cavity Phase 1 (FLD CONT) |  | 43d | 2007-10-01 | 2007-11-30 | 9-080M, 1212121105M | 11d | 0d | SCIENTIST [20.36 h]; COMP SCIENT [81.42 h]; ELEC ENG [81.42 h]; ELEC TECH [50.89 h] | 13,028.33 |  | HOVATER C | 1 | 1 |  | 1.2.1.2.1.2.1 | BILL M |  |  |  |  |  | 08-009 |  |
| 1212121135B |  | PROC Validation Testing on Cavity Phase 2 (FLD CONT) |  | 169d | 2008-08-01 | 2009-04-09 | 1212121135 FS+163d | 1112d |  | PROCUREMENT<$50K 60 NO ESCALATION FY09 | 3,116.34 |  | HOVATER C | 1 | 1 |  | 1.2.1.2.1.2.1 | BILL M |  | 09-012 | EXP0809 |  |  | 08-009 | 08-016 |
| 1212121135Ba |  | FY08 LAB Validation Testing on Cavity Phase 2A (FLD CONT) |  | 42d | 2008-08-01 | 2008-09-30 | 1212121135 FS+163d | 11d | 0d | ELEC TECH [37.06 h]; SCIENTIST [14.82 h]; ELEC ENG [59.29 h] | 6,055.8 |  | HOVATER C | 1 | 1 |  | 1.2.1.2.1.2.1 | BILL M |  |  | EXP0809 |  |  | 08-009 | 08-016 |
| 1212121135Bb |  | FY09 LAB Validation Testing on Cavity Phase 2B (FLD CONT) |  | 127d | 2008-10-01 | 2009-04-09 | 1212121135Ba | 11d | 0d | ELEC TECH [112.05 h]; SCIENTIST [44.82 h]; ELEC ENG [179.28 h] | 18,896.33 |  | HOVATER C | 1 | 1 |  | 1.2.1.2.1.2.1 | BILL M |  |  | EXP0809 |  |  | 08-009 | 08-016 |
| 1212121140 |  | Assess Hardware Dsgn (FLD CONT) |  | 87d | 2009-02-12 | 2009-06-16 | 1212121135Bb FS-40d | 11d | 0d | ELEC TECH [172 h]; ELEC ENG [828 h]; PROCUREMENT<$50K 60; ELEC DES [640 h] | 111,496.72 |  | HOVATER C | 1 | 1 |  | 1.2.1.2.1.2.1 | BILL M | 07-027 |  |  |  |  | 08-009 |  |
| 1212121170 |  | Pre-Constrctn Dsgn Review (FLD CONT) |  | 20d | 2009-05-01 | 2009-05-29 | 1212121135Bb FS+15d | 86d |  | MECH DES [12 h]; MECH ENG [12 h]; ELEC DES [80 h]; ELEC ENG [320 h] | 25,523.8 |  | HOVATER C | 1 | 1 |  | 1.2.1.2.1.2.1 | BILL M |  |  |  |  |  | 08-009 |  |
| 1212121145 |  | Update Documentation and Procurement Prep (FLD CONT)+ |  | 86d | 2009-05-14 | 2009-09-15 | 1212121140 FS-23d | 11d | 0d | ELEC DES [320 h]; OFFICE [80 h]; ELEC ENG [160 h] | 27,068.8 |  | HOVATER C | 1 | 1 |  | 1.2.1.2.1.2.1 | BILL M | 07-027 |  |  |  |  | 08-009 |  |
| 1212121145M |  | Documentation Ready for Prcrmnt (FLD CONT)+ | milestone | 0d | 2009-09-15 | 2009-09-15 | 1212121145 | 11d |  |  |  |  | HOVATER C | 1 | 1 | 5 | 1.2.1.2.1.2.1 | BILL M | 07-027 |  |  |  |  | 08-009 |  |
| 1212121175 |  | Re-Baseline Actuals Adjustment |  | 1d | 2013-08-30 | 2013-08-30 | 9-130M FS+227d | 20d |  | PROCUREMENT>$50K 69 NO ESCALATION | 61,971.9 |  | HOVATER C | 1 | 1 |  |  | BILL M |  |  |  | 13-014 | ADJ |  |  |

Notes:
- 1212113060M: Entry Criteria: Ext Pred: klystron & HPA / sufficiently defined
- 1212113075: Corrective Actions: Cost savings, HOM Filter are Internal & Activity remains to preserve / logic.
- 1212121135: Entry Criteria: Predecessor: 1212121105M (already in baseline)
- 1212121135B: Entry Criteria: Predecessor: 1212121105M (already in baseline)
- 1212121135Ba: Entry Criteria: Predecessor: 1212121105M (already in baseline)
- 1212121135Bb: Entry Criteria: Predecessor: 1212121105M (already in baseline)

| ID | WBS | Activity | Type | Duration | Start | Finish | Predecessors | Total float | Free float | Constraint | Resources | Cost | Planned FinishUDF | RESP - Responsibility | STRT%COMP for CM EVM | FNSH%COMP for CM EVM | Milestone Level | WBS ASSIGNMENT | CAM RESPONSIBLE | CR 07-027 | CR 08-009 | CR 09-012 | CR 08-016 | EXPNS ACT BRIDGING FY SPLIT | CR 13-014 | ReBaseline Actuals Adjustment |
| --- | --- | --- | --- | --- | --- | --- | --- | --- | --- | --- | --- | --- | --- | --- | --- | --- | --- | --- | --- | --- | --- | --- | --- | --- | --- | --- |
|  | 2 | **1.2.1.2.1.2.2 RESONANCE CONTROL & INTERLOCKS** |  |  | 2007-01-04 | 2013-08-30 |  |  |  |  |  |  |  |  |  |  |  |  |  |  |  |  |  |  |  |  |
| 1212122000M |  | Start Preliminary Integrated System Design (RESON CNTL & INTRLCKS) | milestone | 0d | 2007-01-04 | 2007-01-04 | 9-070M FS+60d | 86d | 0d |  |  |  | 2007-01-04 | HOVATER C | 1 | 1 | 5 | 1.2.1.2.1.2.2 | BILL M |  |  |  |  |  |  |  |
| 1212122005 |  | Prepare Preliminary Integrated System Design (RESON CNTL & INTRLCKS) |  | 40d | 2007-01-04 | 2007-03-02 | 1212122000M | 244d | 0d |  | ELEC DES [34.8 h]; COMP SCIENT [69.6 h]; ELEC ENG [104.4 h] | 12,494.24 | 2007-03-02 | HOVATER C | 1 | 1 |  | 1.2.1.2.1.2.2 | BILL M |  |  |  |  |  |  |  |
| 1212122015 |  | Develop Detailed Preliminary Integrated System Design specification (RESON CNTL & INTRLCKS) |  | 20d | 2007-01-04 | 2007-02-01 | 1212122000M | 86d | 0d |  | ELEC ENG [34.8 h] | 2,299.24 | 2007-02-01 | HOVATER C | 1 | 1 |  | 1.2.1.2.1.2.2 | BILL M |  |  |  |  |  |  |  |
| 1212122020M |  | Interlock and Step Chassis (RESON CNTL & INTRLCKS) | milestone | 0d | 2007-02-02 | 2007-02-02 | 1212122015 | 86d | 0d |  |  |  | 2007-02-02 | HOVATER C | 1 | 1 | 5 | 1.2.1.2.1.2.2 | BILL M |  |  |  |  |  |  |  |
| 1212122025 |  | Develop Interlock Preliminary Design (RESON CNTL & INTRLCKS) |  | 60d | 2007-02-02 | 2007-04-27 | 1212122020M | 184d | 0d |  | ELEC DES [208.8 h]; ELEC TECH [104.4 h]; COMP SCIENT [69.6 h]; ELEC ENG [208.8 h]; PROCUREMENT<$50K 60 | 39,658.69 | 2007-04-27 | HOVATER C | 1 | 1 |  | 1.2.1.2.1.2.2 | BILL M |  |  |  |  |  |  |  |
| 1212122010M |  | Preliminary Integrated System Design Complete (RESON CNTL & INTRLCKS) | milestone | 0d | 2007-03-02 | 2007-03-02 | 1212122005 | 244d | 43d |  |  |  | 2007-03-02 | HOVATER C | 1 | 1 | 5 | 1.2.1.2.1.2.2 | BILL M |  |  |  |  |  |  |  |
| 1212122030 |  | Build Design Interlock validation unit (RESON CNTL & INTRLCKS) |  | 10d | 2007-04-30 | 2007-05-11 | 1212122025 | 184d | 0d |  |  |  | 2007-05-11 | HOVATER C | 1 | 1 |  | 1.2.1.2.1.2.2 | BILL M |  |  |  |  |  |  |  |
| 1212122045M |  | Start PZT Driver chassis design (RESON CNTL & INTRLCKS) | milestone | 0d | 2007-05-03 | 2007-05-03 | 1212122020M FS+63d | 86d | 0d |  |  |  | 2007-05-03 | HOVATER C | 1 | 1 | 5 | 1.2.1.2.1.2.2 | BILL M |  |  |  |  |  |  |  |
| 1212122050 |  | Develop PZT Driver chassis Preliminary Design (RESON CNTL & INTRLCKS) |  | 65d | 2007-05-03 | 2007-08-03 | 1212122045M | 86d | 0d |  | PROCUREMENT<$50K 60; COMP SCIENT [69.6 h]; ELEC DES [174 h]; ELEC ENG [139.2 h]; ELEC TECH [104.4 h] | 31,314.24 | 2007-08-03 | HOVATER C | 1 | 1 |  | 1.2.1.2.1.2.2 | BILL M |  |  |  |  |  |  |  |
| 1212122070M |  | Start Cost & Schedule Update (RESON CNTL & INTRLCKS) | milestone | 0d | 2007-05-03 | 2007-05-03 | 1212122010M, 1212122045M | 201d | 0d |  |  |  | 2007-05-03 | HOVATER C | 1 | 1 | 5 | 1.2.1.2.1.2.2 | BILL M |  |  |  |  |  |  |  |
| 1212122075 |  | Update PED Cost and Schedule (RESON CNTL & INTRLCKS) |  | 10d | 2007-05-03 | 2007-05-16 | 1212122070M | 201d | 0d |  | ELEC ENG [34.8 h] | 2,161.78 | 2007-05-16 | HOVATER C | 1 | 1 |  | 1.2.1.2.1.2.2 | BILL M |  |  |  |  |  |  |  |
| 1212122080 |  | Update Construction Cost and Schedule (RESON CNTL & INTRLCKS) |  | 10d | 2007-05-17 | 2007-05-31 | 1212122075 | 201d | 0d |  | ELEC ENG [34.8 h] | 2,161.78 | 2007-05-31 | HOVATER C | 1 | 1 |  | 1.2.1.2.1.2.2 | BILL M |  |  |  |  |  |  |  |
| 1212122085M |  | Resonance Control Ready for Baseline (RESON CNTL & INTRLCKS) | milestone | 0d | 2007-05-31 | 2007-05-31 | 1212122080 | 201d | 115d |  |  |  | 2007-05-31 | HOVATER C | 1 | 1 | 5 | 1.2.1.2.1.2.2 | BILL M |  |  |  |  |  |  |  |
| 1212122035 |  | Interlock Validation Testing (RESON CNTL & INTRLCKS) |  | 60d | 2007-08-01 | 2007-10-24 | 1212122030 FS+55d | 184d | 0d |  | ELEC TECH [34.8 h]; COMP SCIENT [69.6 h]; ELEC ENG [69.6 h] | 9,504.01 | 2007-06-25 | HOVATER C | 1 | 1 |  | 1.2.1.2.1.2.2 | BILL M | 07-027 |  |  |  |  |  |  |
| 1212122055 |  | Build PZT Driver chassis validation unit (RESON CNTL & INTRLCKS) |  | 10d | 2007-08-06 | 2007-08-17 | 1212122050 | 86d | 0d |  |  |  | 2007-08-17 | HOVATER C | 1 | 1 |  | 1.2.1.2.1.2.2 | BILL M |  |  |  |  |  |  |  |
| 1212122060 |  | Conduct PZT Driver chassis Validation testing (RESON CNTL & INTRLCKS) |  | 60d | 2007-08-20 | 2007-11-12 | 1212122055 | 86d | 0d |  | ELEC TECH [34.8 h]; COMP SCIENT [69.6 h]; ELEC ENG [69.6 h] | 9,569.13 | 2007-09-28 | HOVATER C | 1 | 1 |  | 1.2.1.2.1.2.2 | BILL M | 07-027 |  |  |  |  |  |  |
| 1212122040M |  | Interlock Validation Completed (RESON CNTL & INTRLCKS) | milestone | 0d | 2007-10-24 | 2007-10-24 | 1212122035 | 184d | 0d |  |  |  | 2007-06-25 | HOVATER C | 1 | 1 | 5 | 1.2.1.2.1.2.2 | BILL M |  |  |  |  |  |  |  |
| 1212122095 |  | Cavity Interlock Tests P-1(RESON CNTL & INTRLCKS) |  | 25d | 2007-10-25 | 2007-11-30 | 1212122040M | 184d |  |  | COMP SCIENT [40 h]; ELEC ENG [80 h]; ELEC DES [53.34 h]; ELEC TECH [53.34 h] | 11,746.83 |  | HOVATER C | 1 | 1 |  | 1.2.1.2.1.2.2 | BILL M | 07-027 | 08-009 | 09-012 |  |  |  |  |
| 1212122065M |  | PZT Driver chassis Validation test complete (RESON CNTL & INTRLCKS) | milestone | 0d | 2007-11-12 | 2007-11-12 | 1212122060 | 86d | 0d |  |  |  | 2007-09-28 | HOVATER C | 1 | 1 | 5 | 1.2.1.2.1.2.2 | BILL M |  |  |  |  |  |  |  |
| 1212122090 |  | Resonance Cavity Tests P-1 (RESON CNTL & INTRLCKS) |  | 12d | 2007-11-13 | 2007-11-30 | 9-080M, 1212122085M, 1212122065M | 86d | 0d |  | ELEC DES [24 h]; ELEC ENG [36 h]; ELEC TECH [24 h]; SUPPLIES & MATERIALS; COMP SCIENT [36 h] | 6,822.79 |  | HOVATER C | 1 | 1 |  | 1.2.1.2.1.2.2 | BILL M | 07-027 | 08-009 | 09-012 |  |  |  |  |
| 1212122095B |  | FY08 Cavity Interlock Tests P-2 (RESON CNTL & INTRLCKS) |  | 21d | 2008-09-02 | 2008-09-30 | 1212122095 | 0d |  | start on 2008-09-02 | ELEC TECH [7.18 h]; ELEC ENG [28.72 h]; COMP SCIENT [7.18 h] | 2,482.56 |  | HOVATER C | 1 | 1 |  | 1.2.1.2.1.2.2 | BILL M | 07-027 | 08-009 | 09-012 | 08-016 | EXP0809 |  |  |
| 1212122090B |  | FY08 LAB/EXP Resonance Cavity Tests P-2 (RESON CNTL & INTRLCKS) |  | 5d | 2008-09-24 | 2008-09-30 | 1212122090 FS+200d | 86d | 0d |  | COMP SCIENT [1.36 h]; SUPPLIES & MATERIALS; ELEC ENG [6.94 h]; ELEC TECH [1.36 h] | 659.06 |  | HOVATER C | 1 | 1 |  | 1.2.1.2.1.2.2 | BILL M | 07-027 | 08-009 | 09-012 | 08-016 | EXP0809 |  |  |
| 1212122090Ba |  | FY08 LAB/EXP Resonance Cavity Tests P-2 (RESON CNTL & INTRLCKS) |  | 142d | 2008-10-01 | 2009-04-30 | 1212122090B | 86d | 0d |  | COMP SCIENT [38.64 h]; ELEC ENG [197.06 h]; ELEC TECH [38.64 h]; SUPPLIES & MATERIALS | 19,314.31 |  | HOVATER C | 1 | 1 |  | 1.2.1.2.1.2.2 | BILL M | 07-027 | 08-009 |  | 08-016 | EXP0809 |  |  |
| 1212122095Ba |  | FY09 Cavity Interlock Tests P-2 (RESON CNTL & INTRLCKS) |  | 96d | 2008-10-01 | 2009-02-25 | 1212122095B | 7d | 0d |  | COMP SCIENT [32.82 h]; ELEC TECH [32.82 h]; ELEC ENG [131.28 h] | 11,710.17 |  | HOVATER C | 1 | 1 |  | 1.2.1.2.1.2.2 | BILL M | 07-027 | 08-009 |  | 08-016 | EXP0809 |  |  |
| 1212122100 |  | Resonance & Interlock Dsgn Assessmnt (RESON CNTL & INTRLCKS) |  | 107d | 2009-01-21 | 2009-06-22 | 1212122095Ba FS-25d | 7d | 0d |  | ELEC DES [400 h]; ELEC TECH [160 h]; PROCUREMENT<$50K 60; ELEC ENG [545.45 h] | 66,242.36 |  | HOVATER C | 1 | 1 |  | 1.2.1.2.1.2.2 | BILL M | 07-027 | 08-009 | 09-012 |  |  |  |  |
| 1212122170 |  | Pre-Constrctn Dsgn Review (RESON CNTL & INTRLCKS) |  | 20d | 2009-05-01 | 2009-05-29 | 1212122090Ba, 1212122095Ba | 86d |  |  | MECH ENG [12 h]; MECH DES [12 h]; ELEC ENG [80 h] | 6,430.2 |  | HOVATER C | 1 | 1 |  | 1.2.1.2.1.2.2 | BILL M | 07-027 | 08-009 |  |  |  |  |  |
| 1212122105 |  | Update Documentation and Procurement Prep (RESON CNTL & INTRLCKS) |  | 86d | 2009-05-20 | 2009-09-21 | 1212122100 FS-23d | 7d | 0d |  | ELEC TECH [40 h]; ELEC DES [160 h]; OFFICE [40 h] | 10,002.8 |  | HOVATER C | 1 | 1 |  | 1.2.1.2.1.2.2 | BILL M | 07-027 | 08-009 |  |  |  |  |  |
| 1212122110M |  | Documentation Ready for Prcrmnt (RESON CNTL & INTRLCKS)+ | milestone | 0d | 2009-09-21 | 2009-09-21 | 1212122105 | 7d |  |  |  |  |  | HOVATER C | 1 | 1 | 6 | 1.2.1.2.1.2.2 | BILL M | 07-027 | 08-009 |  |  |  |  |  |
| 1212122175 |  | Re-Baseline Actuals Adjustment |  | 1d | 2013-08-30 | 2013-08-30 | 9-130M FS+227d | 20d |  |  | PROCUREMENT>$50K 69 NO ESCALATION | 15,067.41 |  | HOVATER C | 1 | 1 |  |  | BILL M |  |  |  |  |  | 13-014 | ADJ |

Notes:
- 1212122095: Entry Criteria: Ext Pred: / 1212122040M
- 1212122090: Entry Criteria: Ext Pred: / 1212122065M
- 1212122095B: Entry Criteria: Ext Pred: / 1212122040M
- 1212122090B: Entry Criteria: Ext Pred: / 1212122065M
- 1212122090Ba: Entry Criteria: Ext Pred: / 1212122065M
- 1212122095Ba: Entry Criteria: Ext Pred: / 1212122040M

| ID | WBS | Activity | Type | Duration | Start | Finish | Predecessors | Total float | Free float | Resources | Cost | Planned FinishUDF | RESP - Responsibility | STRT%COMP for CM EVM | FNSH%COMP for CM EVM | Milestone Level | WBS ASSIGNMENT | CAM RESPONSIBLE | CR 08-009 | CR 09-012 | CR 08-016 | CR 07-027 | CR 13-014 | ReBaseline Actuals Adjustment | CR 07-024 | Duplications | Profile change |
| --- | --- | --- | --- | --- | --- | --- | --- | --- | --- | --- | --- | --- | --- | --- | --- | --- | --- | --- | --- | --- | --- | --- | --- | --- | --- | --- | --- |
|  | 3 | **1.2.1.2.1.2.3 PACKAGE/INTERFACE** |  |  | 2007-03-15 | 2013-08-30 |  |  |  |  |  |  |  |  |  |  |  |  |  |  |  |  |  |  |  |  |  |
| 1212123000M |  | Start Preliminary Integrated System Design (PKG/INTRFC) | milestone | 0d | 2007-03-15 | 2007-03-15 | 9-070M FS+108d | 301d | 0d |  |  | 2007-03-15 | HOVATER C | 1 | 1 | 6 | 1.2.1.2.1.2.3 | BILL M |  |  |  |  |  |  |  |  |  |
| 1212123005 |  | Develop Preliminary Integrated System Design (PKG/INTRFC) |  | 40d | 2007-03-15 | 2007-05-09 | 1212123000M | 321d | 0d | ELEC ENG [17.4 h]; ELEC TECH [34.8 h]; ELEC DES [34.8 h]; PROCUREMENT<$50K 60 | 7,155.36 | 2007-05-09 | HOVATER C | 1 | 1 |  | 1.2.1.2.1.2.3 | BILL M |  |  |  |  |  |  |  |  |  |
| 1212123015M |  | Start Cost & Schedule Update (PKG/INTRFC) | milestone | 0d | 2007-03-15 | 2007-03-15 | 1212123000M | 301d | 0d |  |  | 2007-03-15 | HOVATER C | 1 | 1 | 5 | 1.2.1.2.1.2.3 | BILL M |  |  |  |  |  |  |  |  |  |
| 1212123020 |  | Update PED Cost and Schedule (PKG/INTRFC) |  | 30d | 2007-03-15 | 2007-04-25 | 1212123015M | 301d | 0d | ELEC ENG [8.7 h] | 554.19 | 2007-04-25 | HOVATER C | 1 | 1 |  | 1.2.1.2.1.2.3 | BILL M |  |  |  |  |  |  |  |  |  |
| 1212123025 |  | Update Construction Cost and Schedule (PKG/INTRFC) |  | 30d | 2007-04-26 | 2007-06-07 | 1212123020 | 301d | 0d | ELEC ENG [8.7 h] | 540.44 | 2007-06-07 | HOVATER C | 1 | 1 |  | 1.2.1.2.1.2.3 | BILL M |  |  |  |  |  |  |  |  |  |
| 1212123010M |  | Preliminary Integrated Design Complete (PKG/INTRFC) | milestone | 0d | 2007-05-09 | 2007-05-09 | 1212123005 | 321d | 20d |  |  | 2007-05-09 | HOVATER C | 1 | 1 | 5 | 1.2.1.2.1.2.3 | BILL M |  |  |  |  |  |  |  |  |  |
| 1212123030M |  | Racks-Interface Ready for Baseline (PKG/INTRFC) | milestone | 0d | 2007-06-07 | 2007-06-07 | 1212123025, 1212123010M | 301d | 232d |  |  | 2007-06-07 | HOVATER C | 1 | 1 | 5 | 1.2.1.2.1.2.3 | BILL M |  |  |  |  |  |  |  |  |  |
| 1212123035 |  | Dsgn Chassis Pwr Supply (PKG/INTRFC) |  | 20d | 2007-10-01 | 2007-10-26 | 9-080M | 69d | 0d | ELEC TECH [80 h]; SUPPLIES & MATERIALS; PROCUREMENT<$50K 60; ELEC ENG [80 h]; ELEC DES [160 h] | 22,671.91 |  | HOVATER C | 1 | 1 |  | 1.2.1.2.1.2.3 | BILL M |  |  |  |  |  |  |  |  |  |
| 1212123040 |  | Proc & Test PS P-1 (PKG/INTRFC) |  | 23d | 2007-10-29 | 2007-11-30 | 1212123035 | 69d | 0d | ELEC DES [110.4 h]; ELEC TECH [55.2 h]; ELEC ENG [36.8 h] | 9,357.69 |  | HOVATER C | 1 | 1 |  | 1.2.1.2.1.2.3 | BILL M | 08-009 | 09-012 |  |  |  |  |  |  |  |
| 1212123040B |  | Proc & Test PS P-2 (PKG/INTRFC) |  | 60d | 2008-02-22 | 2008-05-15 | 1212123040 FS+50d | 69d | 0d | ELEC ENG [43.2 h]; ELEC DES [129.6 h]; ELEC TECH [64.8 h]; PROCUREMENT<$50K 60 | 15,246.86 |  | HOVATER C | 1 | 1 |  | 1.2.1.2.1.2.3 | BILL M | 08-009 |  |  |  |  |  |  |  |  |
| 1212123045 |  | Final Dsgn Rack Layout with FC, Res & PS (PKG/INTRFC) |  | 95d | 2008-05-16 | 2008-09-30 | 1212123030M, 1212123040B | 69d | 0d | PROCUREMENT<$50K 60; ELEC TECH [160 h]; ELEC DES [240 h]; ELEC ENG [80 h] | 26,481.64 |  | HOVATER C | 1 | 1 |  | 1.2.1.2.1.2.3 | BILL M | 08-009 | 09-012 | 08-016 |  |  |  |  |  |  |
| 1212123050 |  | Update Documentation and Procurement Prep(PKG/INTRFC) |  | 179d | 2008-10-01 | 2009-06-23 | 1212123045 | 69d | 0d | ELEC DES [240 h]; ELEC ENG [40 h]; OFFICE [80 h] | 15,682.8 |  | HOVATER C | 1 | 1 |  | 1.2.1.2.1.2.3 | BILL M | 08-009 |  |  | 07-027 |  |  |  |  |  |
| 1212123170 |  | Pre-Constrctn Dsgn Review (PKG/INTRFC) |  | 20d | 2009-05-01 | 2009-05-29 | 1212123045 FS+142d | 86d |  | MECH DES [12 h]; MECH ENG [12 h]; ELEC DES [40 h]; ELEC ENG [40 h] | 5,700.2 |  | HOVATER C | 1 | 1 |  | 1.2.1.2.1.2.3 | BILL M | 08-009 |  |  | 07-027 |  |  |  |  |  |
| 1212123055M |  | Rack Documentation Ready for Prcrmnt (PKG/INTRFC)+ | milestone | 0d | 2009-06-23 | 2009-06-23 | 1212123050 | 69d |  |  |  |  | HOVATER C | 1 | 1 | 6 | 1.2.1.2.1.2.3 | BILL M | 08-009 |  |  | 07-027 |  |  |  |  |  |
| 1212123175 |  | Re-Baseline Actuals Adjustment |  | 1d | 2013-08-30 | 2013-08-30 | 9-130M FS+227d | 20d |  | PROCUREMENT>$50K 69 NO ESCALATION | 10,260.64 |  | HOVATER C | 1 | 1 |  |  | BILL M |  |  |  |  | 13-014 | ADJ |  |  |  |
|  | 4 | **1.2.1.2.1.2.4 CPU & SOFTWARE** |  |  | 2006-11-01 | 2013-08-30 |  |  |  |  |  |  |  |  |  |  |  |  |  |  |  |  |  |  |  |  |  |
| 1212124000M |  | Start Preliminary Integrated System Design (CPU & SW)100 | milestone | 0d | 2006-11-01 | 2006-11-01 | 9-070M FS+22d | 172d | 0d |  |  | 2006-11-01 | HOVATER C | 1 | 1 | 6 | 1.2.1.2.1.2.4 | BILL M |  |  |  |  |  |  |  |  |  |
| 1212124005 |  | Develop Preliminary Integrated System Design (CPU & SW)100 |  | 80d | 2006-11-01 | 2007-03-06 | 1212124000M | 191d | 0d | ELEC ENG [69.6 h]; COMP SCIENT [69.6 h] | 8,629.7 | 2007-03-06 | HOVATER C | 1 | 1 |  | 1.2.1.2.1.2.4 | BILL M |  |  |  |  |  |  |  |  |  |
| 1212124020M |  | Start Embedded IOC Design (CPU & SW)100 | milestone | 0d | 2007-01-02 | 2007-01-02 | 1212124000M FS+36d | 173d | 0d |  |  | 2007-01-02 | HOVATER C | 1 | 1 | 5 | 1.2.1.2.1.2.4 | BILL M |  |  |  |  |  |  |  |  |  |
| 1212124025 |  | Develop Preliminary Embedded IOC Design (CPU & SW)85 |  | 60d | 2007-01-02 | 2007-03-28 | 1212124020M | 173d | 0d | PROCUREMENT<$50K 60; ELEC ENG [29.6 h]; ELEC TECH [29.6 h]; COMP SCIENT [118.4 h] | 14,425.43 | 2007-03-28 | HOVATER C | 1 | 1 |  | 1.2.1.2.1.2.4 | BILL M |  |  |  |  |  |  | 07-024 |  |  |
| 1212124010M |  | Preliminary Integrated Design Complete (CPU & SW)100 | milestone | 0d | 2007-03-06 | 2007-03-06 | 1212124005 | 191d | 0d |  |  | 2007-03-06 | HOVATER C | 1 | 1 | 5 | 1.2.1.2.1.2.4 | BILL M |  |  |  |  |  |  |  |  |  |
| 1212124015 |  | Refine Embedded IOC Detailed specification (CPU & SW)30 |  | 20d | 2007-03-07 | 2007-04-03 | 1212124010M | 191d | 19d | ELEC ENG [10.4 h] | 683.02 | 2007-04-03 | HOVATER C | 1 | 1 |  | 1.2.1.2.1.2.4 | BILL M |  |  |  |  |  |  | 07-024 |  |  |
| 1212124030M |  | Start Validation Unit Testing (CPU & SW) | milestone | 0d | 2007-03-29 | 2007-03-29 | 1212124025 | 173d | 6d |  |  | 2007-03-29 | HOVATER C | 1 | 1 | 5 | 1.2.1.2.1.2.4 | BILL M |  |  |  |  |  |  |  |  |  |
| 1212124045M |  | Start Cost & Schedule Update (CPU & SW)100 | milestone | 0d | 2007-04-03 | 2007-04-03 | 1212124000M FS+99d | 172d | 0d |  |  | 2007-04-03 | HOVATER C | 1 | 1 | 5 | 1.2.1.2.1.2.4 | BILL M |  |  |  |  |  |  |  |  |  |
| 1212124050 |  | Update PED Cost and Schedule (CPU & SW)100 |  | 20d | 2007-04-03 | 2007-04-30 | 1212124045M | 172d | 0d | ELEC ENG [17.4 h] | 1,080.89 | 2007-04-30 | HOVATER C | 1 | 1 |  | 1.2.1.2.1.2.4 | BILL M |  |  |  |  |  |  |  |  |  |
| 1212124035 |  | Conduct Validation Testing w Digital Board (CPU & SW) |  | 42d | 2007-04-06 | 2007-06-05 | 1212121055M, 1212124030M | 167d | 0d | ELEC ENG [160 h]; SUPPLIES & MATERIALS | 10,939.2 | 2007-09-25 | HOVATER C | 1 | 1 |  | 1.2.1.2.1.2.4 | BILL M |  | 09-012 |  | 07-027 |  |  | 07-024 |  |  |
| 1212124055 |  | Update Construction Cost and Schedule (CPU & SW)100 |  | 20d | 2007-05-01 | 2007-05-29 | 1212124015, 1212124050 | 172d | 0d | ELEC ENG [17.4 h] | 1,080.89 | 2007-05-28 | HOVATER C | 1 | 1 |  | 1.2.1.2.1.2.4 | BILL M |  |  |  |  |  |  |  |  |  |
| 1212124060M |  | Controls Ready for Baseline (CPU & SW)100 | milestone | 0d | 2007-05-29 | 2007-05-29 | 1212124055 | 172d | 5d |  |  | 2007-05-28 | HOVATER C | 1 | 1 | 5 | 1.2.1.2.1.2.4 | BILL M |  |  |  |  |  |  |  |  |  |
| 1212124040M |  | Validation Tests Complete (CPU & SW) | milestone | 0d | 2007-06-05 | 2007-06-05 | 1212124060M, 1212124035 | 167d | 81d |  |  | 2007-09-25 | HOVATER C | 1 | 1 | 5 | 1.2.1.2.1.2.4 | BILL M |  |  |  | 07-027 |  |  |  |  |  |
| 1212124065 |  | Program EPICS Interface P-1 (CPU&SW) |  | 43d | 2007-10-01 | 2007-11-30 | 9-080M, 1212124040M | 86d | 0d |  |  |  | HOVATER C | 1 | 1 |  | 1.2.1.2.1.2.4 | BILL M | 08-009 | 09-012 |  |  |  |  | 07-024 | DUP |  |
| 1212124065B |  | Program EPICS Interface P-2 (CPU&SW) |  | 54d | 2008-06-02 | 2008-08-15 | 1212124065 FS+120d | 86d | 0d |  |  |  | HOVATER C | 1 | 1 |  | 1.2.1.2.1.2.4 | BILL M | 08-009 | 09-012 |  |  |  |  | 07-024 |  |  |
| 1212124070M |  | EPICS Ready for Test (CPU&SW) | milestone | 0d | 2008-08-15 | 2008-08-15 | 1212124065B | 86d | 0d |  |  |  | HOVATER C | 1 | 1 | 6 | 1.2.1.2.1.2.4 | BILL M | 08-009 |  |  |  |  |  |  |  |  |
| 1212124075 |  | Cavity Tests & Modifications (CPU&SW) |  | 133d | 2008-09-15 | 2009-04-01 | 1212124070M FS+19d | 86d | 0d |  |  |  | HOVATER C | 1 | 1 |  | 1.2.1.2.1.2.4 | BILL M | 08-009 | 09-012 | 08-016 |  |  |  | 07-024 | DUP |  |
| 1212124080M |  | CPU & Software tested on Cavity (CPU&SW)++ | milestone | 0d | 2009-04-15 | 2009-04-15 | 1212124075 FS+10d | 86d | 0d |  |  |  | HOVATER C | 1 | 1 | 6 | 1.2.1.2.1.2.4 | BILL M | 08-009 |  |  |  |  |  |  |  |  |
| 1212124170 |  | Pre-Constrctn Dsgn Review (CPU&SW)++ |  | 20d | 2009-05-01 | 2009-05-29 | 1212124080M FS+11d | 86d |  |  |  |  | HOVATER C | 1 | 1 |  | 1.2.1.2.1.2.4 | BILL M | 08-009 | 09-012 |  |  |  |  | 07-024 | DUP | C |
| 1212124175 |  | Re-Baseline Actuals Adjustment |  | 1d | 2013-08-30 | 2013-08-30 | 9-130M FS+227d | 20d |  | PROCUREMENT>$50K 69 NO ESCALATION | -24,599.59 |  | HOVATER C | 1 | 1 |  |  | BILL M |  |  |  |  | 13-014 | ADJ |  |  |  |

Notes:
- 1212123035: Entry Criteria: Ext Pred: / 1212123010M
- 1212123045: Entry Criteria: Ext Pred: / 1212123010M
- 1212124065: Entry Criteria: Ext Pred: / 1212124040M
- 1212124065B: Entry Criteria: Ext Pred: / 1212124040M

| ID | WBS | Activity | Type | Duration | Start | Finish | Predecessors | Total float | Free float | Resources | Cost | Planned FinishUDF | RESP - Responsibility | STRT%COMP for CM EVM | FNSH%COMP for CM EVM | Milestone Level | WBS ASSIGNMENT | CAM RESPONSIBLE | CR 07-024 | CR 07-027 | CR 08-009 | CR 08-016 | Duplications | CR 09-012 | CR 13-014 | ReBaseline Actuals Adjustment | EXPNS ACT BRIDGING FY SPLIT |
| --- | --- | --- | --- | --- | --- | --- | --- | --- | --- | --- | --- | --- | --- | --- | --- | --- | --- | --- | --- | --- | --- | --- | --- | --- | --- | --- | --- |
|  | 5 | **1.2.1.2.1.2.5 TEST STAND** |  |  | 2007-03-15 | 2013-08-30 |  |  |  |  |  |  |  |  |  |  |  |  |  |  |  |  |  |  |  |  |  |
| 1212125000M |  | Start Cost & Schedule Update (TEST STAND) | milestone | 0d | 2007-03-15 | 2007-03-15 | 9-070M FS+108d | 26d | 0d |  |  | 2007-03-15 | HOVATER C | 1 | 1 | 6 | 1.2.1.2.1.2.5 | BILL M |  |  |  |  |  |  |  |  |  |
| 1212125005 |  | Update PED Cost and Schedule (TEST STAND) |  | 30d | 2007-03-15 | 2007-04-25 | 1212125000M | 26d | 0d | ELEC ENG [8.7 h] | 554.19 | 2007-04-25 | HOVATER C | 1 | 1 |  | 1.2.1.2.1.2.5 | BILL M |  |  |  |  |  |  |  |  |  |
| 1212125010 |  | Update Construction Cost and Schedule (TEST STAND) |  | 30d | 2007-04-26 | 2007-06-07 | 1212125005 | 26d | 0d | ELEC ENG [8.7 h] | 540.44 | 2007-06-07 | HOVATER C | 1 | 1 |  | 1.2.1.2.1.2.5 | BILL M |  |  |  |  |  |  |  |  |  |
| 1212125015M |  | Test Stand Ready for Baseline (TEST STAND) | milestone | 0d | 2007-06-07 | 2007-06-07 | 1212125010 | 26d | 24d |  |  | 2007-06-07 | HOVATER C | 1 | 1 | 6 | 1.2.1.2.1.2.5 | BILL M |  |  |  |  |  |  |  |  |  |
| 1212125020 |  | Dsgn & Fab RF Test Stand (Test STAND)-seeNotebook Entry |  | 369d | 2008-04-08 | 2009-09-28 | 9-080M FS+125d, 1212125015M FS+180d | 2d | 0d |  |  |  | HOVATER C | 1 | 1 |  | 1.2.1.2.1.2.5 | BILL M | 07-024 | 07-027 | 08-009 | 08-016 | DUP | 09-012 |  |  |  |
| 1212125025M |  | RF Test Stand Ready for Production Tests (TEST STAND)+ | milestone | 0d | 2009-09-28 | 2009-09-28 | 1212125020 | 2d |  |  |  |  | HOVATER C | 1 | 1 | 6 | 1.2.1.2.1.2.5 | BILL M |  | 07-027 | 08-009 |  |  |  |  |  |  |
| 1212125030 |  | Re-Baseline Actuals Adjustment |  | 1d | 2013-08-30 | 2013-08-30 | 9-130M FS+227d | 20d |  | PROCUREMENT>$50K 69 NO ESCALATION | 611.6 |  | HOVATER C | 1 | 1 |  |  | BILL M |  |  |  |  |  |  | 13-014 | ADJ |  |
|  | 6 | **1.2.1.2.1.2.6 MASTER OSCILLATOR** |  |  | 2007-03-15 | 2013-08-30 |  |  |  |  |  |  |  |  |  |  |  |  |  |  |  |  |  |  |  |  |  |
| 1212126000M |  | Start Cost & Schedule Update (MSTR OSC) | milestone | 0d | 2007-03-15 | 2007-03-15 | 9-070M FS+108d | 570d | 0d |  |  | 2007-03-15 | HOVATER C | 1 | 1 | 5 | 1.2.1.2.1.2.6 | BILL M |  |  |  |  |  |  |  |  |  |
| 1212126005 |  | Update PED Cost and Schedule (MSTR OSC) |  | 30d | 2007-03-15 | 2007-04-25 | 1212126000M | 570d | 0d | ELEC ENG [8.7 h] | 554.19 | 2007-04-25 | HOVATER C | 1 | 1 |  | 1.2.1.2.1.2.6 | BILL M |  |  |  |  |  |  |  |  |  |
| 1212126010 |  | Update Construction Cost and Schedule (MSTR OSC) |  | 30d | 2007-04-26 | 2007-06-07 | 1212126005 | 570d | 0d | ELEC ENG [8.7 h] | 540.44 | 2007-06-07 | HOVATER C | 1 | 1 |  | 1.2.1.2.1.2.6 | BILL M |  |  |  |  |  |  |  |  |  |
| 1212126015M |  | MO Ready for Baseline (MSTR OSC) | milestone | 0d | 2007-06-07 | 2007-06-07 | 1212126010 | 570d | 0d |  |  | 2007-06-07 | HOVATER C | 1 | 1 | 5 | 1.2.1.2.1.2.6 | BILL M |  |  |  |  |  |  |  |  |  |
| 1212126170 |  | Pre-Constrctn Dsgn Review (MSTR OSC) |  | 5d | 2007-06-08 | 2007-06-14 | 1212126010, 1212126015M | 570d |  |  |  | 2007-06-14 | HOVATER C | 1 | 1 |  | 1.2.1.2.1.2.6 | BILL M |  |  |  |  |  | 09-012 |  |  |  |
| 1212126175 |  | Re-Baseline Actuals Adjustment |  | 1d | 2013-08-30 | 2013-08-30 | 9-130M FS+227d | 20d |  | PROCUREMENT>$50K 69 NO ESCALATION | 887.72 |  | HOVATER C | 1 | 1 |  |  | BILL M |  |  |  |  |  |  | 13-014 | ADJ |  |
|  | 7 | **1.2.1.2.1.2.7 HPA CONTROL** |  |  | 2006-11-01 | 2013-08-30 |  |  |  |  |  |  |  |  |  |  |  |  |  |  |  |  |  |  |  |  |  |
| 1212127000M |  | Start Preliminary Integrated System Design (HPA CNTRL) | milestone | 0d | 2006-11-01 | 2006-11-01 | 9-070M FS+22d | 243d | 0d |  |  | 2006-11-01 | HOVATER C | 1 | 1 | 5 | 1.2.1.2.1.2.7 | BILL M |  |  |  |  |  |  |  |  |  |
| 1212127005 |  | Develop Preliminary System Design (HPA CNTRL) |  | 50d | 2006-11-01 | 2007-01-22 | 1212127000M | 276d | 0d | ELEC ENG [34.8 h]; ELEC DES [17.6 h] | 3,090.89 | 2007-01-22 | HOVATER C | 1 | 1 |  | 1.2.1.2.1.2.7 | BILL M |  |  |  |  |  | 09-012 |  |  |  |
| 1212127010M |  | Preliminary Design Complete (HPA CNTRL) | milestone | 0d | 2007-01-22 | 2007-01-22 | 1212127005 | 276d | 89d |  |  | 2007-01-22 | HOVATER C | 1 | 1 | 5 | 1.2.1.2.1.2.7 | BILL M |  |  |  |  |  |  |  |  |  |
| 1212127020M |  | Start Cost & Schedule Update (HPA CNTRL) | milestone | 0d | 2007-04-03 | 2007-04-03 | 9-070M FS+121d | 187d | 0d |  |  | 2007-04-03 | HOVATER C | 1 | 1 | 5 | 1.2.1.2.1.2.7 | BILL M |  |  |  |  |  |  |  |  |  |
| 1212127025 |  | Update PED Cost and Schedule (HPA CNTRL) |  | 20d | 2007-04-03 | 2007-04-30 | 1212127020M | 187d | 0d | ELEC ENG [17.4 h] | 1,080.89 | 2007-04-30 | HOVATER C | 1 | 1 |  | 1.2.1.2.1.2.7 | BILL M |  |  |  |  |  |  |  |  |  |
| 1212127030 |  | Update Construction Cost and Schedule (HPA CNTRL) |  | 20d | 2007-05-01 | 2007-05-29 | 1212127025 | 187d | 0d | ELEC ENG [17.4 h] | 1,080.89 | 2007-05-28 | HOVATER C | 1 | 1 |  | 1.2.1.2.1.2.7 | BILL M |  |  |  |  |  |  |  |  |  |
| 1212127035M |  | HPA Controls Ready for Baseline (HPA CNTRL) | milestone | 0d | 2007-05-29 | 2007-05-29 | 1212127030, 1212127010M | 187d | 169d |  |  | 2007-05-28 | HOVATER C | 1 | 1 | 5 | 1.2.1.2.1.2.7 | BILL M |  |  |  |  |  |  |  |  |  |
| 1212127015 |  | Develop Detailed specification P-1 (HPA CNTRL) |  | 43d | 2007-10-01 | 2007-11-30 | 1212127000M, 1212112090M | 18d | 0d | ELEC ENG [8.9 h] | 553.94 | 2006-11-30 | HOVATER C | 1 | 1 |  | 1.2.1.2.1.2.7 | BILL M |  | 07-027 | 08-009 |  |  |  |  |  |  |
| 1212127015B |  | Develop Detailed specification P-2 (HPA CNTRL) |  | 40d | 2007-12-03 | 2008-02-06 | 1212127015 | 18d | 0d | ELEC ENG [8.5 h] | 529.04 | 2006-11-30 | HOVATER C | 1 | 1 |  | 1.2.1.2.1.2.7 | BILL M |  | 07-027 | 08-009 |  |  |  |  |  |  |
| 1212127040 |  | Dsgn HPA Control Board & Chassis (HPA CNTL) |  | 142d | 2008-02-07 | 2008-08-27 | 9-080M, 1212127035M, 1212127015B | 18d | 0d | ELEC ENG [160 h]; ELEC DES [400 h]; ELEC TECH [160 h]; SUPPLIES & MATERIALS; PROCUREMENT<$50K 60 | 38,475.33 |  | HOVATER C | 1 | 1 |  | 1.2.1.2.1.2.7 | BILL M |  |  | 08-009 |  |  |  |  |  |  |
| 1212127045 |  | PROC Test & Validate Dsgn (HPA CNTL) |  | 97d | 2008-09-12 | 2009-02-06 | 1212127040 FS+10d | 35d | 17d | PROCUREMENT<$50K 60 NO ESCALATION FY09 | 5,324.6 |  | HOVATER C | 1 | 1 |  | 1.2.1.2.1.2.7 | BILL M |  |  | 08-009 | 08-016 |  | 09-012 |  |  | EXP0809 |
| 1212127045a |  | FY08 LAB/EXP Test & Validate Dsgn (HPA CNTL) |  | 13d | 2008-09-12 | 2008-09-30 | 1212127040 FS+10d | 18d | 0d | SUPPLIES & MATERIALS; ELEC TECH [21.44 h]; COMP SCIENT [26.8 h]; ELEC DES [53.61 h]; ELEC ENG [16.08 h] | 5,917.17 |  | HOVATER C | 1 | 1 |  | 1.2.1.2.1.2.7 | BILL M |  |  | 08-009 | 08-016 |  |  |  |  | EXP0809 |
| 1212127045b |  | FY09 LAB/EXP Test & Validate Dsgn (HPA CNTL) |  | 84d | 2008-10-01 | 2009-02-06 | 1212127045a | 18d | 0d | SUPPLIES & MATERIALS; COMP SCIENT [173.2 h]; ELEC DES [346.39 h]; ELEC ENG [103.92 h]; ELEC TECH [138.56 h] | 39,459.29 |  | HOVATER C | 1 | 1 |  | 1.2.1.2.1.2.7 | BILL M |  |  | 08-009 | 08-016 |  |  |  |  | EXP0809 |
| 1212127050M |  | HPA Control Dsgn Tested (HPA CNTL) | milestone | 0d | 2009-03-04 | 2009-03-04 | 1212127045, 1212127045b FS+17d | 18d | 0d |  |  |  | HOVATER C | 1 | 1 | 6 | 1.2.1.2.1.2.7 | BILL M |  |  | 08-009 |  |  |  |  |  |  |
| 1212127055 |  | Assess & Modify Dsgn (HPA CNTL) |  | 108d | 2009-03-05 | 2009-08-05 | 1212127050M | 18d | 0d | ELEC DES [160 h]; ELEC ENG [40 h] | 9,926 |  | HOVATER C | 1 | 1 |  | 1.2.1.2.1.2.7 | BILL M |  |  | 08-009 |  |  |  |  |  |  |
| 1212127170 |  | Pre-Constrctn Dsgn Review (HPA CNTL) + |  | 20d | 2009-05-01 | 2009-05-29 | 1212127050M FS+41d | 86d |  | MECH ENG [12 h]; MECH DES [12 h]; ELEC ENG [80 h] | 6,430.2 |  | HOVATER C | 1 | 1 |  | 1.2.1.2.1.2.7 | BILL M |  | 07-027 | 08-009 |  |  |  |  |  |  |
| 1212127060 |  | Update Documentation and Procurement Prep (HPA CNTL) |  | 66d | 2009-06-03 | 2009-09-03 | 1212127055 FS-45d | 18d | 0d | ELEC ENG [40 h]; ELEC DES [160 h] | 9,926 |  | HOVATER C | 1 | 1 |  | 1.2.1.2.1.2.7 | BILL M |  |  | 08-009 |  |  |  |  |  |  |
| 1212127065M |  | HPA control Documentation Ready for Prcrmnt (HPA CNTL)++ | milestone | 0d | 2009-09-03 | 2009-09-03 | 1212127060 | 18d |  |  |  |  | HOVATER C | 1 | 1 | 6 | 1.2.1.2.1.2.7 | BILL M |  |  | 08-009 |  |  |  |  |  |  |
| 1212127175 |  | Re-Baseline Actuals Adjustment |  | 1d | 2013-08-30 | 2013-08-30 | 9-130M FS+227d | 20d |  | PROCUREMENT>$50K 69 NO ESCALATION | -15,117.29 |  | HOVATER C | 1 | 1 |  |  | BILL M |  |  |  |  |  |  | 13-014 | ADJ |  |

Notes:
- 1212125020: Entry Criteria: Ext Pred: / 1212125015M
- 1212127040: Entry Criteria: Ext Pred: / 1212127010M

| ID | WBS | Activity | Type | Duration | Start | Finish | Predecessors | Total float | Free float | Resources | Cost | Planned FinishUDF | RESP - Responsibility | STRT%COMP for CM EVM | FNSH%COMP for CM EVM | Milestone Level | WBS ASSIGNMENT | CAM RESPONSIBLE | CR 07-027 | Profile change | CR 13-014 | ReBaseline Actuals Adjustment |
| --- | --- | --- | --- | --- | --- | --- | --- | --- | --- | --- | --- | --- | --- | --- | --- | --- | --- | --- | --- | --- | --- | --- |
|  | 3 | **1.2.1.2.1.3 INSTALLATION (PED)** |  |  |  |  |  |  |  |  |  |  |  |  |  |  |  |  |  |  |  |  |
|  | 4 | **1.2.1.2.1.4 SYSTEM OPERATION** |  |  |  |  |  |  |  |  |  |  |  |  |  |  |  |  |  |  |  |  |
|  | 2 | **1.2.1.2.2 MAGNET POWER** |  |  | 2006-10-02 | 2013-08-30 |  |  |  |  |  |  |  |  |  |  |  |  |  |  |  |  |
|  | 1 | **1.2.1.2.2.1 BOX SUPPLIES - PED** |  |  | 2006-10-02 | 2013-08-30 |  |  |  |  |  |  |  |  |  |  |  |  |  |  |  |  |
| 121221000M |  | Begin Box PS PED (BOX SUP) | milestone | 0d | 2006-10-02 | 2006-10-02 | 9-070M | 150d | 0d |  |  | 2006-10-02 | MERZ B | 1 | 1 | 5 | 1.2.1.2.2.1 | BILL M |  |  |  |  |
| 121221005 |  | Conduct Spec & Cost Review of Other Projects (BOX SUP) |  | 30d | 2006-10-02 | 2006-11-10 | 121221000M | 150d | 0d | ELEC ENG [139.2 h] | 9,196.94 | 2006-11-10 | MERZ B | 1 | 1 |  | 1.2.1.2.2.1 | BILL M |  |  |  |  |
| 121221010 |  | Travel _ Visit Other Projects (BOX SUP) |  | 30d | 2006-10-02 | 2006-11-10 | 121221000M | 150d | 0d | TRAVEL | 10,320 | 2006-11-10 | MERZ B | 1 | 1 |  | 1.2.1.2.2.1 | BILL M |  |  |  |  |
| 121221015 |  | Refine/Update Preliminary Performance Requirements (BOX SUP) |  | 20d | 2006-11-13 | 2006-12-12 | 121221005, 121221010 | 150d | 0d | ELEC ENG [34.8 h] | 2,299.24 | 2006-12-12 | MERZ B | 1 | 1 |  | 1.2.1.2.2.1 | BILL M |  |  |  |  |
| 121221020M |  | Preliminary Preformance Requirements Update Complete (BOX SUP) | milestone | 0d | 2006-12-12 | 2006-12-12 | 121221015 | 150d | 0d |  |  | 2006-12-12 | MERZ B | 1 | 1 | 5 | 1.2.1.2.2.1 | BILL M |  |  |  |  |
| 121221025M |  | Begin Preliminary Design Box Power Supplies (BOX SUP) | milestone | 0d | 2006-12-13 | 2006-12-13 | 121221020M | 150d | 0d |  |  | 2006-12-13 | MERZ B | 1 | 1 | 5 | 1.2.1.2.2.1 | BILL M |  |  |  |  |
| 121221030 |  | Develop Preliminary PS Design (BOX SUP) |  | 30d | 2006-12-13 | 2007-02-01 | 121221025M | 150d | 0d | ELEC ENG [174 h]; ELEC DES [139.2 h]; ELEC TECH [34.8 h]; COMP SCIENT [104.4 h] | 25,245.67 | 2007-02-01 | MERZ B | 1 | 1 |  | 1.2.1.2.2.1 | BILL M |  |  |  |  |
| 121221035 |  | Review & Revise PS Re-use Plan & Cost Estimate (BOX SUP) |  | 20d | 2007-02-02 | 2007-03-02 | 121221030 | 150d | 0d | ELEC ENG [13.92 h]; ELEC DES [69.6 h]; ELEC TECH [69.6 h] | 6,933.13 | 2007-03-02 | MERZ B | 1 | 1 |  | 1.2.1.2.2.1 | BILL M |  |  |  |  |
| 121221040 |  | Prepare & Conduct Preliminary Design & Safety Review (BOX SUP) |  | 15d | 2007-03-05 | 2007-03-23 | 121221035 | 150d | 0d | ELEC ENG [34.8 h]; TRAVEL | 17,779.24 | 2007-03-23 | MERZ B | 1 | 1 |  | 1.2.1.2.2.1 | BILL M |  |  |  |  |
| 121221045M |  | Preliminary Design & Safety Review Complete (BOX SUP) | milestone | 0d | 2007-03-23 | 2007-03-23 | 121221040 | 150d | 0d |  |  | 2007-03-23 | MERZ B | 1 | 1 | 5 | 1.2.1.2.2.1 | BILL M |  |  |  |  |
| 121221050 |  | Update Cost and Labor Estimates (BOX SUP) |  | 20d | 2007-03-26 | 2007-04-20 | 121221045M | 150d | 0d | ELEC ENG [69.6 h] | 4,392.28 | 2007-04-20 | MERZ B | 1 | 1 |  | 1.2.1.2.2.1 | BILL M |  |  |  |  |
| 121221055 |  | Update Resource Loaded Schedule (BOX SUP) |  | 20d | 2007-04-23 | 2007-05-18 | 121221050 | 150d | 0d | ELEC ENG [69.6 h] | 4,323.55 | 2007-05-18 | MERZ B | 1 | 1 |  | 1.2.1.2.2.1 | BILL M |  |  |  |  |
| 121221065 |  | Investigate Potential Vendors to Develop Bidders list (BOX SUP) |  | 20d | 2007-05-21 | 2007-06-18 | 121221055 | 157d | 0d | ELEC ENG [34.8 h] | 2,161.78 | 2007-06-18 | MERZ B | 1 | 1 |  | 1.2.1.2.2.1 | BILL M |  |  |  |  |
| 121221070 |  | Write Preliminary PS Design Document (BOX SUP) |  | 31d | 2007-06-19 | 2007-08-01 | 121221065 | 157d | 0d | ELEC ENG [34.8 h]; ELEC DES [34.8 h]; COMP SCIENT [34.8 h] | 5,610.02 | 2007-07-31 | MERZ B | 1 | 1 |  | 1.2.1.2.2.1 | BILL M | 07-027 |  |  |  |
| 121221075M |  | Preliminary PS Design Document Complete (BOX SUP) | milestone | 0d | 2007-08-01 | 2007-08-01 | 121221070 | 157d | 41d |  |  | 2007-07-31 | MERZ B | 1 | 1 | 5 | 1.2.1.2.2.1 | BILL M |  |  |  |  |
| 121221085 |  | Develop Dsgn & Specification for 1000 kW Box PS |  | 60d | 2007-10-01 | 2008-01-03 | 121221075M, 9-080M | 116d | 0d | ELEC ENG [80 h]; COMP SCIENT [40 h]; ELEC DES [20 h] | 8,185 |  | MERZ B | 1 | 1 |  | 1.2.1.2.2.1 | BILL M |  |  |  |  |
| 121221090 |  | Develop Dsgn & Specification for 600 kW Box PS |  | 60d | 2007-10-01 | 2008-01-03 | 9-080M | 116d | 0d | COMP SCIENT [40 h]; ELEC DES [20 h]; ELEC ENG [80 h] | 8,185 |  | MERZ B | 1 | 1 |  | 1.2.1.2.2.1 | BILL M |  |  |  |  |
| 121221095 |  | Develop Dsgn & Specification for Low Power (100/30 kW) Box PS |  | 60d | 2007-10-01 | 2008-01-03 | 9-080M | 116d | 0d | ELEC DES [20 h]; ELEC ENG [80 h]; COMP SCIENT [40 h] | 8,185 |  | MERZ B | 1 | 1 |  | 1.2.1.2.2.1 | BILL M |  |  |  |  |
| 121221120 |  | Develop Plan for YA and Shunt PS |  | 30d | 2008-01-04 | 2008-02-15 | 121221095, 121221085, 121221090 | 116d | 0d | ELEC ENG [80 h] | 4,979.2 |  | MERZ B | 1 | 1 |  | 1.2.1.2.2.1 | BILL M |  | C |  |  |
| 121221100 |  | Develop Design Spec for Dummy load |  | 20d | 2008-02-04 | 2008-03-03 | 9-080M FS+80d | 46d | 0d | ELEC DES [80 h]; ELEC ENG [80 h]; ELEC TECH [40 h] | 10,100.4 |  | MERZ B | 1 | 1 |  | 1.2.1.2.2.1 | BILL M |  |  |  |  |
| 121221105 |  | Develop Box PS Re-use Plans |  | 20d | 2008-02-04 | 2008-03-03 | 9-080M FS+80d | 336d | 0d | ELEC ENG [40 h] | 2,489.6 |  | MERZ B | 1 | 1 |  | 1.2.1.2.2.1 | BILL M |  |  |  |  |
| 121221125 |  | Create Bill of Materials & Parts List for YA and Shunt PS |  | 30d | 2008-02-19 | 2008-03-31 | 121221120 | 346d | 80d | ELEC TECH [80 h]; ELEC ENG [40 h]; ELEC DES [40 h] | 7,386 |  | MERZ B | 1 | 1 |  | 1.2.1.2.2.1 | BILL M |  |  |  |  |
| 121221110 |  | Prepare Procurement Plan for Box PS Refurbishment |  | 30d | 2008-03-04 | 2008-04-14 | 121221105 | 336d | 70d | ELEC ENG [160 h] | 9,958.4 |  | MERZ B | 1 | 1 |  | 1.2.1.2.2.1 | BILL M |  |  |  |  |
| 121221135 |  | Pre-Constrctn Final Sys & Safty Review (Box SUPPLIES) |  | 30d | 2008-03-04 | 2008-04-14 | 121221100 | 46d | 0d | ELEC ENG [160 h]; ELEC TECH [20 h] | 10,737 |  | MERZ B | 1 | 1 |  | 1.2.1.2.2.1 | BILL M |  | C |  |  |
| 121221140 |  | Update Cost & Labor Estimates (Box SUPPLIES) |  | 30d | 2008-04-15 | 2008-05-27 | 121221135 | 46d | 0d | ELEC ENG [40 h]; ELEC TECH [20 h] | 3,268.2 |  | MERZ B | 1 | 1 |  | 1.2.1.2.2.1 | BILL M | 07-027 | C |  |  |
| 121221145 |  | Update Schedule (Box SUPPLIES) |  | 30d | 2008-04-15 | 2008-05-27 | 121221135 | 46d | 0d | ELEC TECH [20 h]; ELEC ENG [40 h] | 3,268.2 |  | MERZ B | 1 | 1 |  | 1.2.1.2.2.1 | BILL M | 07-027 | C |  |  |
| 121221150 |  | Prep Final Specification & Prcrmnt Package (Box SUPPLIES)+ |  | 30d | 2008-07-24 | 2008-09-04 | 121221125, 121221140 FS+40d, 121221110, 121221145 FS+40d | 266d | 77d | ELEC ENG [160 h]; COMP SCIENT [40 h] | 12,273.2 |  | MERZ B | 1 | 1 |  | 1.2.1.2.2.1 | BILL M | 07-027 |  |  |  |
| 121221155 |  | Re-Baseline Actuals Adjustment |  | 1d | 2013-08-30 | 2013-08-30 | 9-130M FS+227d | 20d |  | PROCUREMENT>$50K 69 NO ESCALATION | 30,578.01 |  | MERZ B | 1 | 1 |  |  | BILL M |  |  | 13-014 | ADJ |

| ID | WBS | Activity | Type | Duration | Start | Finish | Predecessors | Total float | Free float | Resources | Cost | Planned FinishUDF | RESP - Responsibility | STRT%COMP for CM EVM | FNSH%COMP for CM EVM | Milestone Level | WBS ASSIGNMENT | CAM RESPONSIBLE | CR 09-012 | CR 08-005 | Profile change | CR 07-027 | EXPNS ACT BRIDGING FY SPLIT | CR 13-014 | ReBaseline Actuals Adjustment |
| --- | --- | --- | --- | --- | --- | --- | --- | --- | --- | --- | --- | --- | --- | --- | --- | --- | --- | --- | --- | --- | --- | --- | --- | --- | --- |
|  | 2 | **1.2.1.2.2.2 SHUNTS - PED** |  |  |  |  |  |  |  |  |  |  |  |  |  |  |  |  |  |  |  |  |  |  |  |
|  | 3 | **1.2.1.2.2.3 TRIMS - PED** |  |  | 2006-10-02 | 2013-08-30 |  |  |  |  |  |  |  |  |  |  |  |  |  |  |  |  |  |  |  |
| 121223000M |  | Start Trim PED (TRIMS) | milestone | 0d | 2006-10-02 | 2006-10-02 | 9-070M | 146d | 0d |  |  | 2006-10-02 | MERZ B | 1 | 1 | 5 | 1.2.1.2.2.3 | BILL M |  |  |  |  |  |  |  |
| 121223005 |  | Update Trim PS Counts and System design- update TDR (TRIMS) |  | 65d | 2006-10-02 | 2007-01-10 | 121223000M | 170d | 24d | ELEC ENG [69.6 h] | 4,598.47 | 2007-01-10 | MERZ B | 1 | 1 |  | 1.2.1.2.2.3 | BILL M | 09-012 |  |  |  |  |  |  |
| 121223010 |  | Procure utility chassis sample and Bulk PS sample (TRIMS) |  | 59d | 2006-10-02 | 2007-01-02 | 121223000M | 146d | 0d | PROCUREMENT<$50K 60 | 15,480 | 2007-01-02 | MERZ B | 1 | 1 |  | 1.2.1.2.2.3 | BILL M |  |  |  |  |  |  |  |
| 121223015M |  | Receive sample hardware (TRIMS) | milestone | 0d | 2007-01-02 | 2007-01-02 | 121223010 | 146d | 0d |  |  | 2007-01-02 | MERZ B | 1 | 1 | 5 | 1.2.1.2.2.3 | BILL M |  |  |  |  |  |  |  |
| 121223020 |  | Install samples into Trim test stand and Test (TRIMS) |  | 30d | 2007-01-03 | 2007-02-14 | 121223015M | 146d | 0d | ELEC DES [69.6 h] | 3,130.61 | 2007-02-14 | MERZ B | 1 | 1 |  | 1.2.1.2.2.3 | BILL M | 09-012 |  |  |  |  |  |  |
| 121223025 |  | Update Trim PS Cost estimate (TRIMS) |  | 30d | 2007-02-15 | 2007-03-29 | 121223010, 121223020, 121223005 | 146d | 0d | ELEC ENG [34.8 h] | 2,299.24 | 2007-03-29 | MERZ B | 1 | 1 |  | 1.2.1.2.2.3 | BILL M | 09-012 |  |  |  |  |  |  |
| 121223030 |  | Develop resource loaded schedule (TRIMS) |  | 40d | 2007-03-30 | 2007-05-24 | 121223025 | 146d |  | ELEC ENG [69.6 h] | 4,330.43 | 2007-05-24 | MERZ B | 1 | 1 |  | 1.2.1.2.2.3 | BILL M | 09-012 |  |  |  |  |  |  |
| 121223030M |  | Start Trim FY08 PED (TRIMS) | milestone | 0d | 2007-10-01 | 2007-10-01 | 9-080M | 36d | 0d |  |  |  | MERZ B | 1 | 1 | 6 | 1.2.1.2.2.3 | BILL M |  |  |  |  |  |  |  |
| 121223032 |  | Proc Sample Commercial PS (TRIMS) |  | 60d | 2007-10-01 | 2008-01-03 | 9-080M, 121223030M | 36d | 0d | PROCUREMENT<$50K 60; ELEC ENG [40 h] | 8,681 |  | MERZ B | 1 | 1 |  | 1.2.1.2.2.3 | BILL M |  |  |  |  |  |  |  |
| 121223035 |  | Test Sample PS (TRIMS) |  | 10d | 2008-01-04 | 2008-01-17 | 121223032 | 36d | 0d | ELEC TECH [120 h]; ELEC ENG [40 h] | 7,161.2 |  | MERZ B | 1 | 1 |  | 1.2.1.2.2.3 | BILL M |  |  |  |  |  |  |  |
| 121223040 |  | Develop Specification for 20 amp trim (TRIMS) |  | 30d | 2008-01-18 | 2008-03-03 | 121223035 | 36d | 0d | SUPPLIES & MATERIALS; ELEC ENG [120 h]; ELEC DES [40 h]; COMP SCIENT [40 h] | 13,691.31 |  | MERZ B | 1 | 1 |  | 1.2.1.2.2.3 | BILL M |  |  |  |  |  |  |  |
| 121223045 |  | Prep Trim Sys Database (TRIMS) |  | 30d | 2008-03-04 | 2008-04-14 | 121223040 | 36d | 0d | ELEC ENG [120 h]; COMP SCIENT [160 h] | 16,728 |  | MERZ B | 1 | 1 |  | 1.2.1.2.2.3 | BILL M |  |  |  |  |  |  |  |
| 121223055 |  | Develop Sys Drawings (TRIMS)++ |  | 30d | 2008-04-15 | 2008-05-27 | 121223045 | 36d | 0d | ELEC DES [80 h] | 3,564 |  | MERZ B | 1 | 1 |  | 1.2.1.2.2.3 | BILL M |  | 08-005 |  |  |  |  |  |
| 121223050 |  | Pre-Constrctn Final Sys & Safty Review (TRIMS)++ |  | 10d | 2008-05-28 | 2008-06-10 | 121223045, 121223055 | 36d | 0d | COMP SCIENT [40 h]; ELEC ENG [80 h] | 7,294 |  | MERZ B | 1 | 1 |  | 1.2.1.2.2.3 | BILL M |  | 08-005 | C |  |  |  |  |
| 121223060 |  | FY08 Prep Final Specification & Prcrmnt Package (TRIMS) |  | 78d | 2008-06-11 | 2008-09-30 | 121223055, 9-080M, 121223050 | 196d | 0d | ELEC ENG [72 h] | 4,481.28 |  | MERZ B | 1 | 1 |  | 1.2.1.2.2.3 | BILL M |  | 08-005 |  | 07-027 | EXP0809 |  |  |
| 121223060a |  | FY09 Prep Final Specification & Prcrmnt Package (TRIMS) |  | 52d | 2008-10-01 | 2008-12-15 | 121223060 | 196d |  | ELEC ENG [48 h] | 3,083.04 |  | MERZ B | 1 | 1 |  | 1.2.1.2.2.3 | BILL M |  | 08-005 |  | 07-027 | EXP0809 |  |  |
| 121223065 |  | Re-Baseline Actuals Adjustment |  | 1d | 2013-08-30 | 2013-08-30 | 9-130M FS+227d | 20d |  | PROCUREMENT>$50K 69 NO ESCALATION | 8,131.73 |  | MERZ B | 1 | 1 |  |  | BILL M |  |  |  |  |  | 13-014 | ADJ |
|  | 4 | **1.2.1.2.2.4 INSTALLATION - PED** |  |  | 2006-11-01 | 2013-08-30 |  |  |  |  |  |  |  |  |  |  |  |  |  |  |  |  |  |  |  |
| 121224022 |  | Preliminary Installation Integration (INSTALL) |  | 140d | 2006-11-01 | 2007-05-30 | 9-070M FS+22d | 143d |  | ELEC ENG [69.6 h] | 4,516 | 2007-05-30 | MERZ B | 1 | 1 |  | 1.2.1.2.2.4 | BILL M |  |  |  |  |  |  |  |
| 121224000M |  | Start Installation Planning (INSTALL) | milestone | 0d | 2007-03-15 | 2007-03-15 | 9-070M FS+108d | 125d | 0d |  |  | 2007-03-15 | MERZ B | 1 | 1 | 6 | 1.2.1.2.2.4 | BILL M |  |  |  |  |  |  |  |
| 121224005 |  | Update Trim PS Counts (INSTALL) |  | 10d | 2007-03-15 | 2007-03-28 | 121224000M | 130d | 5d | ELEC ENG [6.96 h] | 459.85 | 2007-03-28 | MERZ B | 1 | 1 |  | 1.2.1.2.2.4 | BILL M |  |  |  |  |  |  |  |
| 121224010 |  | Update Hall D Equipment Layout (INSTALL) |  | 15d | 2007-03-15 | 2007-04-04 | 121224000M | 125d | 0d | ELEC ENG [13.92 h] | 908.7 | 2007-04-04 | MERZ B | 1 | 1 |  | 1.2.1.2.2.4 | BILL M |  |  |  |  |  |  |  |
| 121224015 |  | Develop Trim Installation requirements (INSTALL) |  | 20d | 2007-04-05 | 2007-05-02 | 121224010, 121224005 | 125d | 0d | ELEC ENG [17.4 h]; ELEC DES [17.4 h] | 1,863.54 | 2007-05-02 | MERZ B | 1 | 1 |  | 1.2.1.2.2.4 | BILL M |  |  |  |  |  |  |  |
| 121224020 |  | Develop Box PS Cable Installation requirements (INSTALL) |  | 20d | 2007-04-05 | 2007-05-02 | 121224010 | 125d | 0d | ELEC DES [17.4 h]; ELEC ENG [17.4 h] | 1,863.54 | 2007-05-02 | MERZ B | 1 | 1 |  | 1.2.1.2.2.4 | BILL M |  |  |  |  |  |  |  |
| 121224025 |  | Update cost estimate (INSTALL) |  | 15d | 2007-05-03 | 2007-05-23 | 121224020, 121224015 | 125d | 0d | ELEC ENG [34.8 h] | 2,161.78 | 2007-05-23 | MERZ B | 1 | 1 |  | 1.2.1.2.2.4 | BILL M |  |  |  |  |  |  |  |
| 121224030 |  | Create Installation Plan and schedule (INSTALL) |  | 22d | 2007-05-24 | 2007-06-25 | 121224025 | 125d |  | ELEC ENG [34.8 h] | 2,161.78 | 2007-06-14 | MERZ B | 1 | 1 |  | 1.2.1.2.2.4 | BILL M |  |  |  | 07-027 |  |  |  |
| 121224035 |  | Dsgn & Assemble Proto Box PS Cable Interconnection Sys (Installtn) |  | 50d | 2007-10-01 | 2007-12-11 | 9-080M | 151d | 110d | ELEC ENG [80 h]; ELEC TECH [20 h]; SKLLD TRADE [80 h]; PROCUREMENT<$50K 60; ELEC DES [20 h] | 15,201 |  | MERZ B | 1 | 1 |  | 1.2.1.2.2.4 | BILL M |  |  |  |  |  |  |  |
| 121224040 |  | Review/Revise Cable Lists- DC Pwr, Interlocks, Controls - Develop Installtn Database (Installtn) |  | 60d | 2007-10-01 | 2008-01-03 | 9-080M | 41d | 0d | SUPPLIES & MATERIALS; ELEC ENG [60 h]; ELEC TECH [40 h]; COMP SCIENT [160 h] | 16,676.51 |  | MERZ B | 1 | 1 |  | 1.2.1.2.2.4 | BILL M |  |  |  |  |  |  |  |
| 121224045 |  | Dsgn Cable Tray Layout, Prep Installtn Drawings (Installtn) |  | 20d | 2008-01-04 | 2008-02-01 | 121224040 | 41d | 0d | ELEC DES [60 h]; ELEC ENG [40 h] | 5,162.6 |  | MERZ B | 1 | 1 |  | 1.2.1.2.2.4 | BILL M |  |  |  |  |  |  |  |
| 121224050 |  | Develop Box Supply Shuffle-Rebuild-Install Plan & S/R Plan (Installtn) |  | 20d | 2008-02-04 | 2008-03-03 | 121224045 | 41d | 0d | ELEC TECH [20 h]; ELEC ENG [80 h]; ELEC DES [20 h] | 6,648.8 |  | MERZ B | 1 | 1 |  | 1.2.1.2.2.4 | BILL M |  |  |  |  |  |  |  |
| 121224055 |  | Prep/Dsgn Utility Installtn - LCW & AC Pwr (Installtn) |  | 30d | 2008-03-04 | 2008-04-14 | 121224050 | 41d | 0d | ELEC ENG [20 h]; ELEC DES [80 h]; PROCUREMENT<$50K 60; ELEC TECH [40 h] | 11,690.6 |  | MERZ B | 1 | 1 |  | 1.2.1.2.2.4 | BILL M |  |  |  |  |  |  |  |
| 121224060 |  | Prep Bill of Matrl's & Update Matrl's & Labor Cost Estimate (Installtn) |  | 15d | 2008-04-15 | 2008-05-05 | 121224055 | 41d | 0d | ELEC TECH [40 h]; COMP SCIENT [40 h]; SKLLD TRADE [40 h]; ELEC ENG [40 h] | 7,542 |  | MERZ B | 1 | 1 |  | 1.2.1.2.2.4 | BILL M |  |  |  |  |  |  |  |
| 121224065 |  | Perform Installtn Hazard Analysis & Revise Schedule (Installtn)++ |  | 15d | 2008-05-06 | 2008-05-27 | 121224060 | 41d | 0d | ELEC ENG [80 h] | 4,979.2 |  | MERZ B | 1 | 1 |  | 1.2.1.2.2.4 | BILL M |  |  |  |  |  |  |  |
| 121224999 |  | Pre-Constrctn Final Sys & Safty Review (Installtn)++ |  | 5d | 2008-05-28 | 2008-06-03 | 121224065, 121224035 | 41d |  |  |  |  | MERZ B | 1 | 1 |  | 1.2.1.2.2.4 | BILL M |  |  | C |  |  |  |  |
| 121224070 |  | Re-Baseline Actuals Adjustment |  | 1d | 2013-08-30 | 2013-08-30 | 9-130M FS+227d | 20d |  | PROCUREMENT>$50K 69 NO ESCALATION | 49,727.97 |  | MERZ B | 1 | 1 |  |  | BILL M |  |  |  |  |  | 13-014 | ADJ |

| ID | WBS | Activity | Type | Duration | Start | Finish | Predecessors | Total float | Free float | Resources | Cost | Planned FinishUDF | RESP - Responsibility | STRT%COMP for CM EVM | FNSH%COMP for CM EVM | Milestone Level | CAM RESPONSIBLE | WBS ASSIGNMENT | CR 09-012 | CR 13-014 | ReBaseline Actuals Adjustment | CR 07-010 | CR 07-027 | Profile change |
| --- | --- | --- | --- | --- | --- | --- | --- | --- | --- | --- | --- | --- | --- | --- | --- | --- | --- | --- | --- | --- | --- | --- | --- | --- |
|  | 3 | **1.2.1.3 CRYOGENICS** |  |  | 2006-10-02 | 2013-08-30 |  |  |  |  |  |  |  |  |  |  |  |  |  |  |  |  |  |  |
|  | 1 | **1.2.1.3.1 ACCELERATOR** |  |  | 2006-10-02 | 2013-08-30 |  |  |  |  |  |  |  |  |  |  |  |  |  |  |  |  |  |  |
| 12131010M |  | Preliminary Engineering Design & Safety Review Completed (ACCEL) | milestone | 0d | 2007-01-12 | 2007-01-12 | 12131.04010 | 21d | 0d |  |  | 2007-01-12 | ARENIUS D | 1 | 1 | 5 | DANA A |  |  |  |  |  |  |  |
|  | 01 | **1.2.1.3.1.01 CHL BUILDING LAYOUT & UTILITIES REQ** |  |  | 2006-10-02 | 2013-08-30 |  |  |  |  |  |  |  |  |  |  |  |  |  |  |  |  |  |  |
| 12131.01005 |  | Develop CHL Building Layout and Utility Schedule (CHL BLDG) |  | 15d | 2006-10-02 | 2006-10-20 | 9-070M | 68d | 47d | SR STAFF [104.4 h]; ELEC ENG [104.4 h] | 17,405.83 | 2006-10-20 | ARENIUS D | 1 | 1 |  | DANA A | 1.2.1.3.1.01 | 09-012 |  |  |  |  |  |
| 12131.01010 |  | Re-Baseline Actuals Adjustment |  | 1d | 2013-08-30 | 2013-08-30 | 9-130M FS+227d | 20d |  | PROCUREMENT>$50K 69 NO ESCALATION | -5,734.45 |  | ARENIUS D | 1 | 1 |  | DANA A |  |  | 13-014 | ADJ |  |  |  |
|  | 02 | **1.2.1.3.1.02 CHL SYSTEM P&ID DEVELOPMENT** |  |  |  |  |  |  |  |  |  |  |  |  |  |  |  |  |  |  |  |  |  |  |
|  | 03 | **1.2.1.3.1.03 CHL WARM HELIUM COMPRESSORS** |  |  | 2006-10-02 | 2013-08-30 |  |  |  |  |  |  |  |  |  |  |  |  |  |  |  |  |  |  |
| 12131.03005 |  | Develop Warm Helium Compressor Piping Dsgn, Prelim |  | 62d | 2006-10-02 | 2007-01-05 | 9-070M | 21d | 0d | ELEC DES [52 h]; SUPPLIES & MATERIALS; MECH ENG [104.4 h]; TRAVEL; SR STAFF [20.8 h]; MECH DES [146.16 h]; ELEC ENG [89.09 h] | 25,720.58 | 2007-01-05 | ARENIUS D | 1 | 1 |  | DANA A | 1.2.1.1.1.3 | 09-012 |  |  | 07-010 |  |  |
| 12131.03010 |  | FY-07 Develop Warm Helium Compressor Piping Design Initial Phase Final Design (CHL WARM HEL COMPR) |  | 28d | 2007-04-23 | 2007-05-31 | 12131.06010, 12131.05010 FS-21d | 290d |  | SUPPLIES & MATERIALS; TRAVEL; MECH ENG [111.6 h]; SR STAFF [118.4 h]; MECH DES [28.4 h]; ELEC ENG [22.4 h] | 35,509.04 | 2007-06-26 | ARENIUS D | 1 | 1 |  | DANA A | 1.2.1.1.1.3 | 09-012 |  |  | 07-010 | 07-027 | C |
| 12131.03012 |  | FY-08 Develop Wrm He Cmprssr Piping Dsgn, Initl Phase Final Dsgn |  | 28d | 2008-10-01 | 2008-11-07 | 12131.03010, 9-090M | 140d | 0d | ELEC ENG [200 h]; ELEC DES [120 h]; MECH DES [800 h]; MECH ENG [1520 h] | 150,426.8 |  | ARENIUS D | 1 | 1 |  | DANA A | 1.2.1.1.1.3 |  |  |  |  | 07-027 |  |
| 12131.03015 |  | CHL Warm Helium Compressors++ |  | 75d | 2008-11-10 | 2009-03-06 | 12131.03012, 9-080M | 140d | 0d | SR STAFF [280 h]; MECH ENG [600 h]; ELEC ENG [160 h]; MECH DES [320 h]; ELEC DES [120 h] | 96,904.4 |  | ARENIUS D | 1 | 1 |  | DANA A | 1.2.1.1.1.3 |  |  |  |  |  |  |
| 12131.03020 |  | CHL Warm Helium Compressors Pre-Constrctn Dsgn Review+ |  | 5d | 2009-03-09 | 2009-03-13 | 12131.03015 | 140d |  |  |  |  | ARENIUS D | 1 | 1 |  | DANA A | 1.2.1.1.1.3 |  |  |  |  | 07-027 |  |
| 12131.03025 |  | Re-Baseline Actuals Adjustment |  | 1d | 2013-08-30 | 2013-08-30 | 9-130M FS+227d | 20d |  | PROCUREMENT>$50K 69 NO ESCALATION | -152,043.6 |  | ARENIUS D | 1 | 1 |  | DANA A |  |  | 13-014 | ADJ |  |  |  |
|  | 04 | **1.2.1.3.1.04 CHL COLD BOXES** |  |  | 2006-10-02 | 2013-08-30 |  |  |  |  |  |  |  |  |  |  |  |  |  |  |  |  |  |  |
| 12131.04005 |  | Develop CHL Cold Box Field Piping Design Preliminary (CHL COLD BOX) |  | 62d | 2006-10-02 | 2007-01-05 | 9-070M | 21d | 0d | MECH DES [141.29 h]; SR STAFF [20.8 h]; MECH ENG [151.73 h]; ELEC ENG [41.76 h]; ELEC DES [36.19 h]; SUPPLIES & MATERIALS; TRAVEL | 24,126.59 | 2007-01-05 | ARENIUS D | 1 | 1 |  | DANA A | 1.2.1.3.1.04 | 09-012 |  |  | 07-010 |  |  |
| 12131.04010 |  | Conduct Prelimin Eng Design & Safety Review for WBS 1.2.1.3.1 Elements (CHL COLD BOX) |  | 5d | 2007-01-08 | 2007-01-12 | 12131.03005, 12131.01005, 12131.05005, 12131.04005, 12131.07005, 12131.10005, 12131.06005, 12131.11005 | 21d | 0d | MECH ENG [104.4 h]; SR STAFF [104.4 h]; MECH DES [172.4 h]; ELEC ENG [69.6 h]; ELEC DES [32 h] | 30,636.18 | 2007-01-12 | ARENIUS D | 1 | 1 |  | DANA A | 1.2.1.3.1.04 | 09-012 |  |  | 07-010 |  |  |
| 12131.04015 |  | FY-07 Develop CHL Cold Box Field Piping Design Initial Phase Final Design (CHL COLD BOX) |  | 85d | 2007-01-16 | 2007-05-15 | 12131010M | 146d | 95d | ELEC ENG [76.8 h]; MECH ENG [57.6 h]; SUPPLIES & MATERIALS; TRAVEL; SR STAFF [118.4 h] | 31,848.56 | 2007-05-15 | ARENIUS D | 1 | 1 |  | DANA A | 1.2.1.3.1.04 | 09-012 |  |  | 07-010 |  |  |
| 12131.04017 |  | FY-08 Develop CHL Cold Box Field Piping Dsgn, Final Phase Final Dsgn |  | 65d | 2007-10-01 | 2008-01-10 | 9-080M, 12131.04015 | 51d | 0d | ELEC ENG [160 h]; ELEC DES [120 h]; MECH DES [800 h]; MECH ENG [800 h] | 98,760.4 |  | ARENIUS D | 1 | 1 |  | DANA A | 1.2.1.3.1.04 |  |  |  |  |  |  |
| 12131.04020 |  | P-1 CHL Cold Box, Dsgn Installtn+ |  | 90d | 2008-01-11 | 2008-05-19 | 12131.04017, 9-080M | 51d |  | MECH ENG [480 h]; SUPPLIES & MATERIALS; SR STAFF [120 h]; MECH DES [360 h]; ELEC ENG [80 h] | 64,081.39 |  | ARENIUS D | 1 | 1 |  | DANA A | 1.2.1.3.1.04 |  |  |  |  | 07-027 |  |
| 12131.04025 |  | P-2 CHL Cold Box, Dsgn Installtn+ |  | 90d | 2009-01-05 | 2009-05-12 | 1331.02000 FS-188d | 98d |  | SUPPLIES & MATERIALS; MECH DES [400 h]; SR STAFF [160 h]; MECH ENG [480 h]; ELEC ENG [80 h] | 72,025.66 |  | ARENIUS D | 1 | 1 |  | DANA A | 1.2.1.3.1.04 |  |  |  |  | 07-027 |  |
| 12131.04030 |  | Re-Baseline Actuals Adjustment |  | 1d | 2013-08-30 | 2013-08-30 | 9-130M FS+227d | 20d |  | PROCUREMENT>$50K 69 NO ESCALATION | 64,773.06 |  | ARENIUS D | 1 | 1 |  | DANA A |  |  | 13-014 | ADJ |  |  |  |
|  | 05 | **1.2.1.3.1.05 CHL OIL REMOVAL SYSTEMS** |  |  | 2006-10-02 | 2013-08-30 |  |  |  |  |  |  |  |  |  |  |  |  |  |  |  |  |  |  |
| 12131.05005 |  | Develop Oil Removal Equipment Fabricaton Drawings Preliminary (CHL OIL REM SYS) |  | 62d | 2006-10-02 | 2007-01-05 | 9-070M | 21d | 0d | MECH DES [31.32 h]; ELEC DES [10.44 h]; MECH ENG [15.31 h]; ELEC ENG [15.31 h] | 3,815.34 | 2007-01-05 | ARENIUS D | 1 | 1 |  | DANA A | 1.2.1.3.1.05 |  |  |  |  |  |  |
| 12131.05010 |  | Develop Oil Removal Equipment Fabricaton Drawings Initial Phase Final Design (CHL OIL REM SYS) |  | 28d | 2007-03-23 | 2007-05-01 | 12131.06010 FS-21d | 304d | 14d | ELEC DES [59.16 h]; MECH ENG [89.09 h]; MECH DES [177.48 h]; ELEC ENG [89.09 h] | 21,576.26 | 2007-05-16 | ARENIUS D | 1 | 1 |  | DANA A | 1.2.1.3.1.05 |  |  |  |  | 07-027 |  |
| 12131.05020 |  | Re-Baseline Actuals Adjustment |  | 1d | 2013-08-30 | 2013-08-30 | 9-130M FS+227d | 20d |  | PROCUREMENT>$50K 69 NO ESCALATION | 29,510.61 |  | ARENIUS D | 1 | 1 |  | DANA A |  |  | 13-014 | ADJ |  |  |  |

Notes:
- 12131.03015: Entry Criteria: Ext Pred: 1.3.3.1.1
- 12131.03020: Entry Criteria: Ext Pred: 1.3.3.1.1
- 12131.04020: Entry Criteria: Ext Pred: / 1.3.3.1.2
- 12131.04025: Entry Criteria: Ext Pred: / 1.3.3.1.2

| ID | WBS | Activity | Duration | Start | Finish | Predecessors | Total float | Free float | Resources | Cost | Planned FinishUDF | RESP - Responsibility | STRT%COMP for CM EVM | FNSH%COMP for CM EVM | WBS ASSIGNMENT | CAM RESPONSIBLE | CR 13-014 | ReBaseline Actuals Adjustment | CR 07-010 | CR 07-027 | ACT BRIDGING FY SPLIT | CR 08-016 | EXPNS ACT BRIDGING FY SPLIT | CR 09-012 | Profile change |
| --- | --- | --- | --- | --- | --- | --- | --- | --- | --- | --- | --- | --- | --- | --- | --- | --- | --- | --- | --- | --- | --- | --- | --- | --- | --- |
|  | 06 | **1.2.1.3.1.06 CHL GAS MANAGEMENT RACK** |  | 2006-10-02 | 2013-08-30 |  |  |  |  |  |  |  |  |  |  |  |  |  |  |  |  |  |  |  |  |
| 12131.06005 |  | Develop Gas Management Rack Assembly and Fabrication Drawings Preliminary (CHL GAS MNGMT RACK) | 62d | 2006-10-02 | 2007-01-05 | 9-070M | 21d | 0d | MECH DES [20.88 h]; ELEC DES [16.01 h]; ELEC ENG [16.01 h] | 2,703.3 | 2007-01-05 | ARENIUS D | 1 | 1 | 1.2.1.3.1.06 | DANA A |  |  |  |  |  |  |  |  |  |
| 12131.06010 |  | Develop Gas Management Rack Assembly and Fabrication Drawings Initial Phase Final Design (CHL GAS MNGMT RACK) | 28d | 2007-03-14 | 2007-04-20 | 12131010M FS+40d | 290d | 0d | ELEC DES [88.39 h]; ELEC ENG [88.39 h]; MECH DES [118.32 h] | 14,835.98 | 2007-04-20 | ARENIUS D | 1 | 1 | 1.2.1.3.1.06 | DANA A |  |  |  |  |  |  |  |  |  |
| 12131.06015 |  | Re-Baseline Actuals Adjustment | 1d | 2013-08-30 | 2013-08-30 | 9-130M FS+227d | 20d |  | PROCUREMENT>$50K 69 NO ESCALATION | 12,173.85 |  | ARENIUS D | 1 | 1 |  | DANA A | 13-014 | ADJ |  |  |  |  |  |  |  |
|  | 07 | **1.2.1.3.1.07 CHL SYSTEM INSTRUMENTATION & CONTROLS** |  | 2006-10-02 | 2013-08-30 |  |  |  |  |  |  |  |  |  |  |  |  |  |  |  |  |  |  |  |  |
| 12131.07005 |  | Develop CHL Instrumentation and Controls Assembly Design Preliminary (CHL SYS INSTR & CNTRLS) | 62d | 2006-10-02 | 2007-01-05 | 9-070M | 21d | 0d | ELEC DES [183.05 h]; SUPPLIES & MATERIALS; PROCUREMENT<$50K 60; ELEC ENG [350.09 h] | 34,158.81 | 2007-01-05 | ARENIUS D | 1 | 1 | 1.2.1.3.1.07 | DANA A |  |  | 07-010 |  |  |  |  |  |  |
| 12131.07010 |  | FY-07 Develop CHL Instrumentation and Controls Assembly Design Initial Phase Final Design (CHL SYS INSTR & CNTRLS) | 180d | 2007-01-16 | 2007-09-28 | 12131010M | 21d | 0d | SUPPLIES & MATERIALS; ELEC ENG [181.6 h]; ELEC DES [114.8 h]; PROCUREMENT<$50K 60 | 32,253.79 | 2007-09-28 | ARENIUS D | 1 | 1 | 1.2.1.3.1.07 | DANA A |  |  | 07-010 |  |  |  |  |  |  |
| 12131.07012 |  | FY-08 Develop CHL Inst & Controls Assy Dsgn, Initl Phase Final Dsgn | 150d | 2007-10-01 | 2008-05-12 | 12131.07010, 9-080M | 21d | 0d | ELEC DES [360 h]; ELEC ENG [720 h] | 60,850.8 |  | ARENIUS D | 1 | 1 | 1.2.1.3.1.07 | DANA A |  |  |  | 07-027 |  |  |  |  |  |
| 12131.07015 |  | PROC Engineer CHL Sys Instrmenttn & Controls+ | 325d | 2008-05-13 | 2009-08-31 | 12131.07012 | 21d |  | PROCUREMENT<$50K 60 NO ESCALATION FY09 | 7,450.32 |  | ARENIUS D | 1 | 1 | 1.2.1.3.1.07 | DANA A |  |  |  | 07-027 | FY08-09 | 08-016 | EXP0809 | 09-012 |  |
| 12131.07015a |  | FY08 LAB/EXP Engineer CHL Sys Instrmenttn & Controls+ | 98d | 2008-05-13 | 2008-09-30 | 12131.07012 | 21d | 0d | ELEC DES [84.43 h]; SUPPLIES & MATERIALS; ELEC ENG [156.8 h] | 15,770.26 |  | ARENIUS D | 1 | 1 | 1.2.1.3.1.07 | DANA A |  |  |  | 07-027 | FY08-09 | 08-016 | EXP0809 |  |  |
| 12131.07015b |  | FY09 LAB/EXP Engineer CHL Sys Instrmenttn & Controls+ | 227d | 2008-10-01 | 2009-08-31 | 12131.07015a | 21d |  | SUPPLIES & MATERIALS; ELEC DES [195.57 h]; ELEC ENG [363.2 h] | 37,697.85 |  | ARENIUS D | 1 | 1 | 1.2.1.3.1.07 | DANA A |  |  |  | 07-027 | FY08-09 | 08-016 | EXP0809 |  |  |
| 12131.07020 |  | Re-Baseline Actuals Adjustment | 1d | 2013-08-30 | 2013-08-30 | 9-130M FS+227d | 20d |  | PROCUREMENT>$50K 69 NO ESCALATION | 164,930.64 |  | ARENIUS D | 1 | 1 |  | DANA A | 13-014 | ADJ |  |  |  |  |  |  |  |
|  | 08 | **1.2.1.3.1.08 CHL INSTRUMENT AIR SYSTEM** |  | 2009-04-08 | 2013-08-30 |  |  |  |  |  |  |  |  |  |  |  |  |  |  |  |  |  |  |  |  |
| 12131.08000 |  | CHL Instrument Air Sys Engrng+ | 100d | 2009-04-08 | 2009-08-27 | 9-090M FS+125d | 23d |  | MECH ENG [560 h]; MECH DES [560 h]; ELEC DES [120 h] | 65,801.6 |  | ARENIUS D | 1 | 1 | 1.2.1.3.1.08 | DANA A |  |  |  | 07-027 |  |  |  |  |  |
| 12131.08010 |  | Re-Baseline Actuals Adjustment | 1d | 2013-08-30 | 2013-08-30 | 9-130M FS+227d | 20d |  | PROCUREMENT>$50K 69 NO ESCALATION | -64,644.64 |  | ARENIUS D | 1 | 1 |  | DANA A | 13-014 | ADJ |  |  |  |  |  |  |  |
|  | 09 | **1.2.1.3.1.09 MOTOR CONTROL CENTERS** |  | 2009-04-08 | 2013-08-30 |  |  |  |  |  |  |  |  |  |  |  |  |  |  |  |  |  |  |  |  |
| 12131.09000 |  | Motor Control Center Specification Development+ | 30d | 2009-04-08 | 2009-05-19 | 9-090M FS+125d | 93d |  | ELEC DES [80 h]; ELEC ENG [120 h]; MECH DES [40 h] | 13,139.6 |  | ARENIUS D | 1 | 1 | 1.2.1.3.1.09 | DANA A |  |  |  | 07-027 |  |  |  |  |  |
| 12131.09005 |  | Re-Baseline Actuals Adjustment | 1d | 2013-08-30 | 2013-08-30 | 9-130M FS+227d | 20d |  | PROCUREMENT>$50K 69 NO ESCALATION | -4,580.24 |  | ARENIUS D | 1 | 1 |  | DANA A | 13-014 | ADJ |  |  |  |  |  |  |  |
|  | 10 | **1.2.1.3.1.10 CHL INSTALLATION DESIGN** |  | 2006-10-02 | 2013-08-30 |  |  |  |  |  |  |  |  |  |  |  |  |  |  |  |  |  |  |  |  |
| 12131.10005 |  | Develop Utility Field Piping Installation Design Preliminary (CHL INSTAL DES) | 55d | 2006-10-02 | 2006-12-19 | 9-070M | 28d | 7d | MECH ENG [278.4 h]; MECH DES [626.4 h] | 44,962.29 | 2006-12-19 | ARENIUS D | 1 | 1 | 1.2.1.3.1.10 | DANA A |  |  |  |  |  |  |  |  |  |
| 12131.10010 |  | Engineer & Dsgn CHL Installtn+ | 180d | 2007-10-01 | 2008-06-24 | 9-080M | 26d |  | ELEC DES [200 h]; SR STAFF [240 h]; ELEC ENG [240 h]; MECH DES [720 h]; SUPPLIES & MATERIALS; MECH ENG [320 h] | 104,527.86 |  | ARENIUS D | 1 | 1 | 1.2.1.3.1.10 | DANA A |  |  |  |  |  |  |  |  | C |
| 12131.10015 |  | Re-Baseline Actuals Adjustment | 1d | 2013-08-30 | 2013-08-30 | 9-130M FS+227d | 20d |  | PROCUREMENT>$50K 69 NO ESCALATION | -99,346.46 |  | ARENIUS D | 1 | 1 |  | DANA A | 13-014 | ADJ |  |  |  |  |  |  |  |
|  | 11 | **1.2.1.3.1.11 CHL COMMISSIONING PLANNING** |  | 2006-10-02 | 2013-08-30 |  |  |  |  |  |  |  |  |  |  |  |  |  |  |  |  |  |  |  |  |
| 12131.11005 |  | Develop CHL Commissioning Design and Plan Preliminary (CHL COMMIS) | 35d | 2006-10-02 | 2006-11-17 | 9-070M | 48d | 27d | MECH ENG [348 h]; ELEC ENG [174 h]; MECH TECH [522 h]; ELEC TECH [174 h] | 60,960.9 | 2006-11-17 | ARENIUS D | 1 | 1 | 1.2.1.3.1.11 | DANA A |  |  |  |  |  |  |  |  |  |
| 12131.11010 |  | Develop CHL Cmmssng Plan++ | 45d | 2008-01-04 | 2008-03-10 | 9-080M FS+60d | 101d |  | ELEC ENG [160 h]; MECH ENG [280 h] | 27,273.6 |  | ARENIUS D | 1 | 1 | 1.2.1.3.1.11 | DANA A |  |  |  | 07-027 |  |  |  |  | C |
| 12131.11015 |  | Re-Baseline Actuals Adjustment | 1d | 2013-08-30 | 2013-08-30 | 9-130M FS+227d | 20d |  | PROCUREMENT>$50K 69 NO ESCALATION | -52,272.73 |  | ARENIUS D | 1 | 1 |  | DANA A | 13-014 | ADJ |  |  |  |  |  |  |  |

Notes:
- 12131.10010: Entry Criteria: Ext Pred: 1.2.1.3.1.5; / 1.2.1.3.1.6; 1.2.1.3.1.1
- 12131.11010: Entry Criteria: Ext Pred: 1.2.1.3.1.2 system / P&ID which is / complete

| ID | WBS | Activity | Type | Duration | Start | Finish | Predecessors | Total float | Free float | Resources | Cost | RESP - Responsibility | STRT%COMP for CM EVM | FNSH%COMP for CM EVM | CR 07-027 | WBS ASSIGNMENT | CAM RESPONSIBLE | CR 13-014 | ReBaseline Actuals Adjustment | Planned FinishUDF | Milestone Level | CR 09-005 | EXPNS ACT BRIDGING FY SPLIT | CR 08-058 |
| --- | --- | --- | --- | --- | --- | --- | --- | --- | --- | --- | --- | --- | --- | --- | --- | --- | --- | --- | --- | --- | --- | --- | --- | --- |
|  | 12 | **1.2.1.3.1.12 LINAC TRANSFER LINE** |  |  |  |  |  |  |  |  |  |  |  |  |  |  |  |  |  |  |  |  |  |  |
|  | 2 | **1.2.1.3.2 HALL D** |  |  | 2009-01-12 | 2013-08-30 |  |  |  |  |  |  |  |  |  |  |  |  |  |  |  |  |  |  |
|  | 1 | **1.2.1.3.2.1 CHL-HALL D TRANSFER LINE** |  |  |  |  |  |  |  |  |  |  |  |  |  |  |  |  |  |  |  |  |  |  |
|  | 2 | **1.2.1.3.2.2 HALL D COLD BOX** |  |  | 2009-04-08 | 2013-08-30 |  |  |  |  |  |  |  |  |  |  |  |  |  |  |  |  |  |  |
| 121322000 |  | Evaluate H-D Refrigerator Cold Box+ |  | 35d | 2009-04-08 | 2009-05-27 | 9-090M FS+125d | 88d |  | ELEC ENG [40 h]; MECH ENG [120 h] | 10,226.4 | ARENIUS D | 1 | 1 | 07-027 | 1.2.1.3.2.2 | DANA A |  |  |  |  |  |  |  |
| 121322005 |  | Re-Baseline Actuals Adjustment |  | 1d | 2013-08-30 | 2013-08-30 | 9-130M FS+227d | 20d |  | PROCUREMENT>$50K 69 NO ESCALATION | 15,582.69 | ARENIUS D | 1 | 1 |  |  | DANA A | 13-014 | ADJ |  |  |  |  |  |
|  | 3 | **1.2.1.3.2.3 HALL D DISTRIBUTION SYSTEM** |  |  | 2009-01-12 | 2013-08-30 |  |  |  |  |  |  |  |  |  |  |  |  |  |  |  |  |  |  |
| 121323000 |  | Dsgn H-D Refrigerator Interconnecting Piping+ |  | 110d | 2009-01-12 | 2009-06-17 | 9-090M FS+65d | 3d | 0d | MECH ENG [240 h]; MECH DES [480 h] | 36,357.6 | ARENIUS D | 1 | 1 | 07-027 | 1.2.1.3.2.3 | DANA A |  |  |  |  |  |  |  |
| 121323005 |  | Re-Baseline Actuals Adjustment |  | 1d | 2013-08-30 | 2013-08-30 | 9-130M FS+227d | 20d |  | PROCUREMENT>$50K 69 NO ESCALATION | -36,357.61 | ARENIUS D | 1 | 1 |  |  | DANA A | 13-014 | ADJ |  |  |  |  |  |
|  | 4 | **1.2.1.3.2.4 INSTRUMENTATION & CONTROLS** |  |  | 2009-06-18 | 2013-08-30 |  |  |  |  |  |  |  |  |  |  |  |  |  |  |  |  |  |  |
| 121324000 |  | Dsgn H-D Refrgerator Controls+ |  | 70d | 2009-06-18 | 2009-09-25 | 121323000 | 3d |  | ELEC ENG [360 h]; ELEC DES [160 h] | 30,479.6 | ARENIUS D | 1 | 1 | 07-027 | 1.2.1.3.2.4 | DANA A |  |  |  |  |  |  |  |
| 121324005 |  | Re-Baseline Actuals Adjustment |  | 1d | 2013-08-30 | 2013-08-30 | 9-130M FS+227d | 20d |  | PROCUREMENT>$50K 69 NO ESCALATION | 436.04 | ARENIUS D | 1 | 1 |  |  | DANA A | 13-014 | ADJ |  |  |  |  |  |
|  | 5 | **1.2.1.3.2.5 U-TUBES** |  |  | 2009-04-08 | 2013-08-30 |  |  |  |  |  |  |  |  |  |  |  |  |  |  |  |  |  |  |
| 121325000 |  | Dsgn H-D Refrigerator U-Tubes+ |  | 25d | 2009-04-08 | 2009-05-12 | 9-090M FS+125d | 98d |  | MECH ENG [80 h]; MECH DES [80 h] | 8,612 | ARENIUS D | 1 | 1 | 07-027 | 1.2.1.3.2.5 | DANA A |  |  |  |  |  |  |  |
| 121325005 |  | Re-Baseline Actuals Adjustment |  | 1d | 2013-08-30 | 2013-08-30 | 9-130M FS+227d | 20d |  | PROCUREMENT>$50K 69 NO ESCALATION | -8,612.02 | ARENIUS D | 1 | 1 |  |  | DANA A | 13-014 | ADJ |  |  |  |  |  |
|  | 6 | **1.2.1.3.2.6 FIELD INSTALLATION** |  |  |  |  |  |  |  |  |  |  |  |  |  |  |  |  |  |  |  |  |  |  |
|  | 7 | **1.2.1.3.2.7 COMMISSIONING** |  |  |  |  |  |  |  |  |  |  |  |  |  |  |  |  |  |  |  |  |  |  |
|  | 4 | **1.2.1.4 BEAM TRANSPORT** |  |  | 2006-10-02 | 2013-08-30 |  |  |  |  |  |  |  |  |  |  |  |  |  |  |  |  |  |  |
|  | 1 | **1.2.1.4.1 SPREADERS & RECOMBINERS** |  |  | 2006-10-02 | 2013-08-30 |  |  |  |  |  |  |  |  |  |  |  |  |  |  |  |  |  |  |
|  | 1 | **1.2.1.4.1.1 DIPOLES** |  |  | 2006-10-02 | 2013-08-30 |  |  |  |  |  |  |  |  |  |  |  |  |  |  |  |  |  |  |
| 121411007LOE |  | FY07 Management of S/R PED Effort (DIPOLES) |  | 247d | 2006-10-02 | 2007-09-28 | 9-070M | 20d | 0d | SUPPLIES & MATERIALS; SCIENTIST [139.2 h]; MECH TECH [104.4 h]; MECH ENG [452.4 h] | 61,290.85 | BEVINS M | 1 | 1 |  | 1.2.1.4.1.1 | MIKE B |  |  | 2007-09-28 |  |  |  |  |
| 121411025 |  | Develop Preliminary design of S/R Dipoles and Septa (DIPOLES) |  | 110d | 2006-10-02 | 2007-03-16 | 9-070M | 404d | 0d | MECH DES [208.8 h]; MECH ENG [417.6 h] | 35,047.08 | BEVINS M | 1 | 1 |  | 1.2.1.4.1.1 | MIKE B |  |  | 2007-03-16 |  |  |  |  |
| 121411015 |  | Beam Transport Physics Design & Safety Review (DIPOLES) |  | 30d | 2006-12-06 | 2007-01-25 | 9-070M FS+45d | 109d | 0d | SCIENTIST [69.6 h] | 4,467.62 | BEVINS M | 1 | 1 |  | 1.2.1.4.1.1 | MIKE B |  |  | 2007-01-25 |  |  |  |  |
| 121411015M |  | Beam Transport Physics Design & Safety Review Completed (DIPOLES) | milestone | 0d | 2007-01-25 | 2007-01-25 | 121411015 | 109d |  |  |  | BEVINS M | 1 | 1 |  | 1.2.1.4.1.1 | MIKE B |  |  | 2007-01-25 | 5 |  |  |  |
| 121411030 |  | Preliminary Design & Safety Review of S/R Dipoles and Septa (DIPOLES) |  | 20d | 2007-02-16 | 2007-03-16 | 121411025 FS-20d | 404d | 0d | MECH DES [35.6 h]; MECH ENG [35.6 h] | 3,776.81 | BEVINS M | 1 | 1 |  | 1.2.1.4.1.1 | MIKE B |  |  | 2007-03-16 |  |  |  |  |
| 121411030M |  | S/R Dipoles & Septa Preliminary Design & Safety Review Completed (DIPOLES) | milestone | 0d | 2007-03-16 | 2007-03-16 | 121411030 | 404d | 0d |  |  | BEVINS M | 1 | 1 |  | 1.2.1.4.1.1 | MIKE B |  |  | 2007-03-16 | 5 |  |  |  |
| 121411035 |  | FY07 Develop Detailed Design of West curved dipoles (DIPOLES) |  | 137d | 2007-03-19 | 2007-09-28 | 121411030M | 404d | 0d | MECH ENG [194.6 h]; MECH DES [340.55 h] | 26,386.84 | BEVINS M | 1 | 1 |  | 1.2.1.4.1.1 | MIKE B |  |  | 2007-09-28 |  |  |  |  |
| 121411045 |  | FY07 Develop Detailed Design of New 3m Septa (DIPOLES) |  | 137d | 2007-03-19 | 2007-09-28 | 121411030M | 496d | 59d | MECH DES [459.2 h]; MECH ENG [291.9 h] | 37,381.02 | BEVINS M | 1 | 1 |  | 1.2.1.4.1.1 | MIKE B |  |  | 2007-09-28 |  |  |  |  |
| 121411055 |  | Develop Detailed Design of New AG and 2m AH Replacements (DIPOLES) |  | 110d | 2007-03-19 | 2007-08-21 | 121411030M | 464d | 0d | MECH ENG [139.2 h]; MECH DES [382.8 h] | 24,976.44 | BEVINS M | 1 | 1 |  | 1.2.1.4.1.1 | MIKE B |  |  | 2007-08-21 |  |  |  |  |
| 121411020 |  | Installation Cost Schedule and Safety Review (DIPOLES) |  | 20d | 2007-05-09 | 2007-06-06 | 9-070M FS+147d | 517d | 0d | MECH ENG [69.6 h] | 4,317.98 | BEVINS M | 1 | 1 |  | 1.2.1.4.1.1 | MIKE B |  |  | 2007-06-06 |  |  |  |  |
| 121411020M |  | Installation Cost Schedule and Safety Review Complete (DIPOLES) | milestone | 0d | 2007-06-06 | 2007-06-06 | 121411020 | 517d | 80d |  |  | BEVINS M | 1 | 1 |  | 1.2.1.4.1.1 | MIKE B |  |  | 2007-06-06 | 5 |  |  |  |
| 121411060M |  | Finish All New S/R C Shaped Dipoles (DIPOLES) | milestone | 0d | 2007-08-21 | 2007-08-21 | 121411055 | 464d | 27d |  |  | BEVINS M | 1 | 1 | 07-027 | 1.2.1.4.1.1 | MIKE B |  |  | 2007-08-21 | 5 |  |  |  |
| 121411036 |  | Develop Detailed Dsgn of West Curved Dipoles (S/R Dipoles) |  | 59d | 2007-10-01 | 2008-01-02 | 121411035 | 404d | 253d | MECH ENG [120 h]; MECH DES [240 h] | 17,616 | BEVINS M | 1 | 1 |  | 1.2.1.4.1.1 | MIKE B |  |  |  |  | 09-005 |  |  |
| 121411046 |  | Develop Detailed Dsgn of New 3m Septa (S/R Dipoles) |  | 59d | 2007-10-01 | 2008-01-02 | 121411020M, 121411060M, 9-080M | 437d | 0d | MECH ENG [400 h]; MECH DES [760 h] | 57,020.8 | BEVINS M | 1 | 1 |  | 1.2.1.4.1.1 | MIKE B |  |  |  |  |  |  |  |
| 121411075 |  | Detailed Dsgn of New 2m Septa (S/R Dipoles) |  | 130d | 2007-10-01 | 2008-04-14 | 9-080M | 366d | 323d | MECH ENG [200 h]; MECH DES [360 h] | 27,660.8 | BEVINS M | 1 | 1 |  | 1.2.1.4.1.1 | MIKE B |  |  |  |  |  |  |  |
| 121411080 |  | Detailed Dsgn of New 2m Narrow Pole Septa (S/R Dipoles) |  | 195d | 2007-10-01 | 2008-07-16 | 9-080M | 301d | 258d | MECH DES [640 h]; MECH ENG [320 h] | 46,976 | BEVINS M | 1 | 1 |  | 1.2.1.4.1.1 | MIKE B |  |  |  |  |  |  |  |
| 121411908LOE |  | FY08 Mngmnt of S/R PED Effort (S/R Dipoles) |  | 248d | 2007-10-01 | 2008-09-30 | 121411007LOE | 20d | 0d | SCIENTIST [160 h]; MECH TECH [200 h]; SR STAFF [680 h]; SUPPLIES & MATERIALS; MECH ENG [200 h] | 110,322.8 | BEVINS M | 1 | 1 |  | 1.2.1.4.1.1 | MIKE B |  |  |  |  |  |  |  |
| 121411065 |  | Detailed Dsgn of East Curved Dipoles (S/R Dipoles) |  | 130d | 2007-12-03 | 2008-06-13 | 9-080M FS+43d | 323d | 145d | MECH ENG [320 h]; MECH DES [560 h] | 43,577.6 | BEVINS M | 1 | 1 |  | 1.2.1.4.1.1 | MIKE B |  |  |  |  | 09-005 |  |  |
| 121411050M |  | Detailed Dsgn of New 3m Septa Comp (S/R DIPOLES) | milestone | 0d | 2008-01-02 | 2008-01-02 | 121411046, 121411045 | 437d | 394d |  |  | BEVINS M | 1 | 1 |  | 1.2.1.4.1.1 | MIKE B |  |  |  | 6 |  |  |  |
| 121411090 |  | FY08 Top Assy Dsgns for Modified S/R Dipoles (S/R Dipoles) |  | 128d | 2008-04-01 | 2008-09-30 | 9-080M FS+120d | 226d | 0d | MECH ENG [273.07 h]; MECH DES [887.47 h] | 54,586.38 | BEVINS M | 1 | 1 | 07-027 | 1.2.1.4.1.1 | MIKE B |  |  |  |  |  | EXP0809 |  |
| 121411090a |  | FY09 Top Assy Dsgns for Modified S/R Dipoles (S/R Dipoles) |  | 22d | 2008-10-01 | 2008-10-30 | 121411090 | 226d | 183d | MECH DES [152.53 h]; MECH ENG [46.93 h] | 9,681.52 | BEVINS M | 1 | 1 | 07-027 | 1.2.1.4.1.1 | MIKE B |  |  |  |  |  | EXP0809 |  |
| 121411909LOE |  | FY09 Mngmnt of S/R PED Effort (S/R Dipoles) |  | 248d | 2008-10-01 | 2009-09-30 | 121411908LOE, 121433908LOE | 20d | 0d | SR STAFF [480 h]; SCIENTIST [120 h] | 57,074.4 | BEVINS M | 1 | 1 |  | 1.2.1.4.1.1 | MIKE B |  |  |  |  |  |  |  |
| 13411909LOEXD |  | FY09 Mngmnt & Oversight (S/R Dipoles) |  | 59d | 2008-10-01 | 2008-12-24 | 12155908LOE, 121411908LOE, 9-090M | 20d | 0d | SR STAFF [123.71 h]; TRAVEL | 19,660.87 | BEVINS M | 1 | 1 |  |  | MIKE B |  |  |  |  |  |  | 08-058 |
| 121411066 |  | Design Option B of East XM Curved Dipoles (S/R Dipoles) |  | 29d | 2008-12-01 | 2009-01-16 | 9-090M FS+41d | 178d | 0d | PLABOR; MECH ENG [80 h] | 24,118 | BEVINS M | 1 | 1 |  | 1.2.1.4.1.1 | MIKE B |  |  |  |  | 09-005 |  |  |
| 121411085 |  | Top Leg Return Dsgns for Trapezoid Dipoles (S/R Dipoles) |  | 40d | 2009-01-05 | 2009-03-03 | 9-090M FS+60d | 148d | 105d | MECH ENG [80 h]; MECH DES [160 h] | 12,119.2 | BEVINS M | 1 | 1 | 07-027 | 1.2.1.4.1.1 | MIKE B |  |  |  |  |  |  |  |
| 121411038 |  | Design Option B of West XV Curved Dipoles (S/R Dipoles) |  | 33d | 2009-01-09 | 2009-02-26 | 9-090M FS+64d, 121411036 | 151d | 5d | MECH ENG [80 h]; PLABOR | 24,118 | BEVINS M | 1 | 1 |  | 1.2.1.4.1.1 | MIKE B |  |  |  |  | 09-005 |  |  |
| 121411081 |  | Design New Dipole for Launch into ARC 10 (S/R Dipoles) |  | 33d | 2009-01-12 | 2009-02-27 | 9-090M FS+65d | 150d | 107d | PLABOR; MECH ENG [80 h] | 24,118 | BEVINS M | 1 | 1 |  | 1.2.1.4.1.1 | MIKE B |  |  |  |  | 09-005 |  |  |
| 121411037 |  | Design Option B of West XU Curved Dipoles (S/R Dipoles) |  | 33d | 2009-01-16 | 2009-03-05 | 9-090M FS+69d | 146d | 0d | PLABOR; MECH ENG [80 h] | 24,118 | BEVINS M | 1 | 1 |  | 1.2.1.4.1.1 | MIKE B |  |  |  |  | 09-005 |  |  |
| 121411070M |  | Dsgn of East Curved Dipoles Comp (S/R DIPOLES) | milestone | 0d | 2009-01-16 | 2009-01-16 | 121411066, 121411065 | 178d | 135d |  |  | BEVINS M | 1 | 1 |  | 1.2.1.4.1.1 | MIKE B |  |  |  | 6 | 09-005 |  |  |
| 121411040M |  | Dsgn of West Curved Dipoles Comp (S/R DIPOLES) | milestone | 0d | 2009-03-05 | 2009-03-05 | 121411036, 121411037, 121411038 | 146d | 103d |  |  | BEVINS M | 1 | 1 |  | 1.2.1.4.1.1 | MIKE B |  |  |  | 6 | 09-005 |  |  |
| 121411091 |  | East Option B Top Assy Dsgns for Modified S/R Dipoles (S/R Dipoles) |  | 64d | 2009-04-01 | 2009-06-30 | 9-090M FS+120d | 64d | 21d | MECH ENG [240 h]; PLABOR | 45,194 | BEVINS M | 1 | 1 | 07-027 | 1.2.1.4.1.1 | MIKE B |  |  |  |  | 09-005 | EXP0809 |  |
| 121411092 |  | West Option B Top Assy Dsgns for Modified S/R Dipoles (S/R Dipoles) |  | 63d | 2009-05-01 | 2009-07-30 | 9-090M FS+142d | 43d | 0d | MECH ENG [240 h]; PLABOR | 45,194 | BEVINS M | 1 | 1 | 07-027 | 1.2.1.4.1.1 | MIKE B |  |  |  |  | 09-005 | EXP0809 |  |
| 121411110M |  | All S/R Dipole & Septa Dsgns Comp (S/R DIPOLES)++ | milestone | 0d | 2009-07-30 | 2009-07-30 | 121411092, 121411070M, 121411090a, 121411091, 121411040M, 121411080, 121411085, 121411050M, 121411075, 121411081 | 43d | 0d |  |  | BEVINS M | 1 | 1 |  | 1.2.1.4.1.1 | MIKE B |  |  |  | 6 | 09-005 |  |  |
| 121411120 |  | Re-Baseline Actuals Adjustment |  | 1d | 2013-08-30 | 2013-08-30 | 9-130M FS+227d | 20d |  | PROCUREMENT>$50K 69 NO ESCALATION | 147,016.32 | BEVINS M | 1 | 1 |  |  | MIKE B | 13-014 | ADJ |  |  |  |  |  |

Notes:
- 121411090: Steps: Core Modifications and H-steel of S/R Dipoles; Parts updated for S/R Dipoles; Top Assembly of East S/R Dipoles; Top Assembly of West S/R Dipoles
- 121411090a: Steps: Core Modifications and H-steel of S/R Dipoles; Parts updated for S/R Dipoles; Top Assembly of East S/R Dipoles; Top Assembly of West S/R Dipoles

| ID | WBS | Activity | Type | Duration | Start | Finish | Predecessors | Total float | Free float | Resources | Cost | Planned FinishUDF | RESP - Responsibility | STRT%COMP for CM EVM | FNSH%COMP for CM EVM | WBS ASSIGNMENT | CAM RESPONSIBLE | Milestone Level | ACT BRIDGING FY SPLIT | EXPNS ACT BRIDGING FY SPLIT | CR 07-027 | CR 09-005 | CR 13-014 | ReBaseline Actuals Adjustment | CR 10-065 | CR 08-029 | CR 08-058 |
| --- | --- | --- | --- | --- | --- | --- | --- | --- | --- | --- | --- | --- | --- | --- | --- | --- | --- | --- | --- | --- | --- | --- | --- | --- | --- | --- | --- |
|  | 2 | **1.2.1.4.1.2 QUADRUPOLES** |  |  |  |  |  |  |  |  |  |  |  |  |  |  |  |  |  |  |  |  |  |  |  |  |  |
|  | 3 | **1.2.1.4.1.3 CORRECTORS** |  |  |  |  |  |  |  |  |  |  |  |  |  |  |  |  |  |  |  |  |  |  |  |  |  |
|  | 4 | **1.2.1.4.1.4 STANDS** |  |  | 2006-11-01 | 2013-08-30 |  |  |  |  |  |  |  |  |  |  |  |  |  |  |  |  |  |  |  |  |  |
| 121414005 |  | Develop Preliminary S/R Stand and Layout Design (STANDS) |  | 110d | 2006-11-01 | 2007-04-17 | 9-070M FS+22d | 231d | 0d | MECH DES [522 h]; MECH ENG [313.2 h] | 42,458.89 | 2007-04-17 | BEVINS M | 1 | 1 | 1.2.1.4.1.4 | MIKE B |  |  |  |  |  |  |  |  |  |  |
| 121414010 |  | Preliminary Design & Safety Review of Stands (STANDS) |  | 20d | 2007-03-21 | 2007-04-17 | 121414005 FS-20d | 231d | 0d | MECH ENG [34.8 h]; MECH DES [34.8 h] | 3,685.25 | 2007-04-17 | BEVINS M | 1 | 1 | 1.2.1.4.1.4 | MIKE B |  |  |  |  |  |  |  |  |  |  |
| 121414010M |  | Preliminary S/R Stand and Layout Design & Safety Review Completed (STANDS) | milestone | 0d | 2007-04-17 | 2007-04-17 | 121414010 | 231d | 173d |  |  | 2007-04-17 | BEVINS M | 1 | 1 | 1.2.1.4.1.4 | MIKE B | 5 |  |  |  |  |  |  |  |  |  |
| 121414015 |  | FY08 Detailed Dsgn of East S/R (S/R Stands) PED++ |  | 190d | 2008-01-02 | 2008-09-30 | 9-080M FS+58d, 121414010M | 58d | 0d | MECH ENG [360 h]; PLABOR; MECH DES [1120 h] | 97,701.3 |  | BEVINS M | 1 | 1 | 1.2.1.4.1.4 | MIKE B |  | FY08-09 | EXP0809 |  |  |  |  |  |  |  |
| 121414020 |  | FY08 Detailed Dsgn of West S/R (S/R Stands)++ |  | 113d | 2008-04-22 | 2008-09-30 | 9-080M FS+135d | 1d | 0d | MECH DES [891.44 h]; PLABOR; MECH ENG [301.33 h] | 73,993.33 |  | BEVINS M | 1 | 1 | 1.2.1.4.1.4 | MIKE B |  | FY08-09 | EXP0809 | 07-027 |  |  |  |  |  |  |
| 121414015a |  | FY09 Detailed Dsgn of East S/R (S/R Stands) PED++ |  | 190d | 2008-10-01 | 2009-07-09 | 121414015 | 58d |  | MECH ENG [360 h]; PLABOR; MECH DES [1120 h] | 100,822.48 |  | BEVINS M | 1 | 1 | 1.2.1.4.1.4 | MIKE B |  | FY08-09 | EXP0809 |  |  |  |  |  |  |  |
| 121414020a |  | FY09 Detailed Dsgn of West S/R (S/R Stands)++ |  | 247d | 2008-10-01 | 2009-09-29 | 121414020 | 1d |  | PLABOR; MECH ENG [658.67 h]; MECH DES [1948.56 h] | 166,906.09 |  | BEVINS M | 1 | 1 | 1.2.1.4.1.4 | MIKE B |  | FY08-09 | EXP0809 | 07-027 |  |  |  |  |  |  |
| 121414016 |  | Incorporate Changes B to the Modified East S/R (S/R Dipoles) |  | 118d | 2009-03-02 | 2009-08-14 | 9-090M FS+98d | 32d |  | MECH ENG [320 h]; PLABOR | 112,768 |  | BEVINS M | 1 | 1 | 1.2.1.4.1.1 | MIKE B |  |  | EXP0809 | 07-027 | 09-005 |  |  |  |  |  |
| 121414025 |  | Re-Baseline Actuals Adjustment |  | 1d | 2013-08-30 | 2013-08-30 | 9-130M FS+227d | 20d |  | PROCUREMENT>$50K 69 NO ESCALATION | -8,517 |  | BEVINS M | 1 | 1 |  | MIKE B |  |  |  |  |  | 13-014 | ADJ |  |  |  |
|  | 5 | **1.2.1.4.1.5 GIRDERS** |  |  |  |  |  |  |  |  |  |  |  |  |  |  |  |  |  |  |  |  |  |  |  |  |  |
|  | 6 | **1.2.1.4.1.6 VACUUM** |  |  | 2008-02-04 | 2013-08-30 |  |  |  |  |  |  |  |  |  |  |  |  |  |  |  |  |  |  |  |  |  |
| 121416000 |  | FY08 Detailed Dsgn of East S/R Dipole Chambers (S/R Vac)++ |  | 168d | 2008-02-04 | 2008-09-30 | 9-080M FS+80d | 211d | 0d | MECH DES [705.6 h]; MECH ENG [218.4 h] | 43,479.75 |  | BEVINS M | 1 | 1 | 1.2.1.4.1.6 | MIKE B |  |  | EXP0809 | 07-027 |  |  |  | 10-065 |  |  |
| 121416005 |  | FY08 Detailed Dsgn of West S/R Dipole Chambers (S/R Vac)++ |  | 118d | 2008-04-15 | 2008-09-30 | 121416000a FS-150d | 246d | 0d | MECH DES [393.33 h]; MECH ENG [78.67 h] | 21,573.61 |  | BEVINS M | 1 | 1 | 1.2.1.4.1.6 | MIKE B |  |  | EXP0809 | 07-027 |  |  |  |  |  |  |
| 121416000a |  | FY09 Detailed Dsgn of East S/R Dipole Chambers (S/R Vac)++ |  | 32d | 2008-10-01 | 2008-11-13 | 121416000 | 211d | 0d | MECH DES [134.4 h]; MECH ENG [41.6 h] | 8,546.6 |  | BEVINS M | 1 | 1 | 1.2.1.4.1.6 | MIKE B |  |  | EXP0809 | 07-027 |  |  |  | 10-065 |  |  |
| 121416005a |  | FY09 Detailed Dsgn of West S/R Dipole Chambers (S/R Vac)++ |  | 2d | 2008-10-01 | 2008-10-02 | 121416005 | 246d | 213d | MECH ENG [1.33 h]; MECH DES [6.67 h] | 377.28 |  | BEVINS M | 1 | 1 | 1.2.1.4.1.6 | MIKE B |  |  | EXP0809 | 07-027 |  |  |  |  |  |  |
| 121416010 |  | Pre-Constrctn Dsgn Review for S/R's++ |  | 5d | 2009-06-04 | 2009-06-10 | 121411110M FS-40d, 121414020a FS-300d, 121414015a FS-300d, 121416000a, 121416005a FS-50d | 78d | 1d |  |  |  | BEVINS M | 1 | 1 | 1.2.1.4.1.6 | MIKE B |  |  |  |  | 09-005 |  |  | 10-065 |  |  |
| 121416015 |  | Re-Baseline Actuals Adjustment |  | 1d | 2013-08-30 | 2013-08-30 | 9-130M FS+227d | 20d |  | PROCUREMENT>$50K 69 NO ESCALATION | -36,756.97 |  | BEVINS M | 1 | 1 |  | MIKE B |  |  |  |  |  | 13-014 | ADJ |  |  |  |
|  | 7 | **1.2.1.4.1.7 INSTALLATION** |  |  |  |  |  |  |  |  |  |  |  |  |  |  |  |  |  |  |  |  |  |  |  |  |  |
|  | 2 | **1.2.1.4.2 EXISTING ARCS (1-9, A, B, & C)** |  |  | 2006-10-02 | 2013-08-30 |  |  |  |  |  |  |  |  |  |  |  |  |  |  |  |  |  |  |  |  |  |
|  | 1 | **1.2.1.4.2.1 DIPOLES** |  |  | 2006-10-02 | 2013-08-30 |  |  |  |  |  |  |  |  |  |  |  |  |  |  |  |  |  |  |  |  |  |
| 121421005 |  | Develop Partial Design of Arc Dipole H-Iron (DIPOLES) |  | 80d | 2006-10-02 | 2007-02-01 | 9-070M | 598d | 0d | MECH DES [278.4 h]; MECH ENG [139.2 h] | 20,938.46 | 2007-02-01 | BEVINS M | 1 | 1 | 1.2.1.4.2.1 | MIKE B |  |  |  |  |  |  |  |  |  |  |
| 121421010 |  | Preliminary Design & Safety Review of Existing Arcs Dipoles (DIPOLES) |  | 20d | 2007-01-04 | 2007-02-01 | 121421005 FS-20d | 598d | 0d | MECH DES [34.8 h]; MECH ENG [34.8 h] | 3,691.93 | 2007-02-01 | BEVINS M | 1 | 1 | 1.2.1.4.2.1 | MIKE B |  |  |  |  |  |  |  |  |  |  |
| 121421010M |  | Existing Arcs Dipoles Preliminary Design & Safety Review Completed (DIPOLES) | milestone | 0d | 2007-02-01 | 2007-02-01 | 121424005, 121421005, 121421010 | 598d | 415d |  |  | 2007-02-01 | BEVINS M | 1 | 1 | 1.2.1.4.2.1 | MIKE B | 5 |  |  |  |  |  |  |  |  |  |
| 121421908LOE |  | FY08 Mngmnt of Existing Arcs (EXIST ARC Dipoles) |  | 248d | 2007-10-01 | 2008-09-30 | 9-080M, 121411007LOE | 20d | 0d | SR STAFF [240 h]; SUPPLIES & MATERIALS | 45,753.4 |  | BEVINS M | 1 | 1 | 1.2.1.4.2.1 | MIKE B |  |  |  |  |  |  |  |  |  |  |
| 121421020 |  | Finish Dsgn of Arc Dipole H-Iron (EXIST ARC Dipoles) ++ |  | 60d | 2008-10-01 | 2009-01-02 | 121421010M, 9-090M | 183d | 0d | MECH DES [360 h]; MECH ENG [80 h] | 20,887.2 |  | BEVINS M | 1 | 1 | 1.2.1.4.2.1 | MIKE B |  |  |  | 07-027 |  |  |  |  |  |  |
| 13421909LOEXD |  | FY09 Mngmnt & Oversight (EXIST ARC Dipoles) |  | 59d | 2008-10-01 | 2008-12-24 | 121421908LOE | 20d | 0d | SR STAFF [66.61 h]; TRAVEL | 12,339.62 |  | BEVINS M | 1 | 1 |  | MIKE B |  |  |  |  |  |  |  |  | 08-029 | 08-058 |
| 121421021 |  | Add H Steel to ARC 1 & 2 Design (S/R Dipoles) |  | 31d | 2009-03-17 | 2009-04-28 | 121421020 FS+49d | 279d | 0d | MECH ENG [120 h]; PLABOR | 21,239 |  | BEVINS M | 1 | 1 | 1.2.1.4.1.1 | MIKE B |  |  | EXP0809 | 07-027 | 09-005 |  |  | 10-065 |  |  |
| 121421022 |  | Synchrotron Radiation Compensation Design (S/R Dipoles) |  | 19d | 2009-04-28 | 2009-05-22 | 121421021 FS-1d | 281d | 182d | MECH ENG [160 h]; PLABOR | 23,792 |  | BEVINS M | 1 | 1 | 1.2.1.4.1.1 | MIKE B |  |  | EXP0809 | 07-027 | 09-005 |  |  | 10-065 |  |  |
| 121421025 |  | Re-Baseline Actuals Adjustment |  | 1d | 2013-08-30 | 2013-08-30 | 9-130M FS+227d | 20d |  | PROCUREMENT>$50K 69 NO ESCALATION | -79,179.11 |  | BEVINS M | 1 | 1 |  | MIKE B |  |  |  |  |  | 13-014 | ADJ |  |  |  |

Notes:
- 121414015: Corrective Actions: Changed Purchased labor from $34K to $54K based on input from LH 050907 - / RKC / From MWiseman Rev B -2.xls
- 121414020: Corrective Actions: Changed Purchased labor from $34K to $54K based on input from LH 050907 - / RKC / From MWiseman Rev B -2.xls / Steps: West S/R Layouts developed with CASA; Design West S/R New/Modified Quad Girders; Detail West S/R New/Modified Quad Girders; Design West S/R Stands and Brackets; Detail West S/R Stands and Brackets
- 121414015a: Corrective Actions: Changed Purchased labor from $34K to $54K based on input from LH 050907 - / RKC / From MWiseman Rev B -2.xls
- 121414020a: Corrective Actions: Changed Purchased labor from $34K to $54K based on input from LH 050907 - / RKC / From MWiseman Rev B -2.xls / Steps: West S/R Layouts developed with CASA; Design West S/R New/Modified Quad Girders; Detail West S/R New/Modified Quad Girders; Design West S/R Stands and Brackets; Detail West S/R Stands and Brackets
- 121414016: Steps: Design & Detail East Modified Girders; Design East Stands; Design East Brackets; Detail East Stands & Brackets; Layout NE and SE Spreader Region
- 121416000: Steps: East S/R Dipole/Septa Layouts developed with CASA; Engineering Vacuum Design Complete; Overall Vacuum Design Complete; Design of Vacuum Chambers Complete; Detail East S/R Vac Chambers
- 121416005: Steps: West S/R Dipole/Septa Layouts developed with CASA; Engineering Vacuum Design Complete; Overall Vacuum Design Complete; Design of Vacuum Chambers Complete; Detail West S/R Vac Chambers
- 121416000a: Steps: East S/R Dipole/Septa Layouts developed with CASA; Engineering Vacuum Design Complete; Overall Vacuum Design Complete; Design of Vacuum Chambers Complete; Detail East S/R Vac Chambers
- 121416005a: Steps: West S/R Dipole/Septa Layouts developed with CASA; Engineering Vacuum Design Complete; Overall Vacuum Design Complete; Design of Vacuum Chambers Complete; Detail West S/R Vac Chambers

| ID | WBS | Activity | Duration | Start | Finish | Predecessors | Total float | Free float | Resources | Cost | RESP - Responsibility | STRT%COMP for CM EVM | FNSH%COMP for CM EVM | CAM RESPONSIBLE | CR 08-029 | CR 08-058 | CR 13-014 | ReBaseline Actuals Adjustment | Planned FinishUDF | CR 07-003 | WBS ASSIGNMENT | CR 07-027 |
| --- | --- | --- | --- | --- | --- | --- | --- | --- | --- | --- | --- | --- | --- | --- | --- | --- | --- | --- | --- | --- | --- | --- |
|  | 2 | **1.2.1.4.2.2 QUADRUPOLES** |  | 2008-10-01 | 2013-08-30 |  |  |  |  |  |  |  |  |  |  |  |  |  |  |  |  |  |
| 13422035XD |  | Prcrmnt Prep for Quads (EXIST ARC Q-POLES) | 59d | 2008-10-01 | 2008-12-24 | 9-090M | 1477d | 0d | MECH ENG [77.8 h]; MECH DES [51.87 h] | 7,238.4 | BEVINS M | 1 | 1 | MIKE B | 08-029 | 08-058 |  |  |  |  |  |  |
| 121422000 |  | Re-Baseline Actuals Adjustment | 1d | 2013-08-30 | 2013-08-30 | 9-130M FS+227d | 20d |  | PROCUREMENT>$50K 69 NO ESCALATION | -6,312.01 | BEVINS M | 1 | 1 | MIKE B |  |  | 13-014 | ADJ |  |  |  |  |
|  | 3 | **1.2.1.4.2.3 CORRECTORS** |  |  |  |  |  |  |  |  |  |  |  |  |  |  |  |  |  |  |  |  |
|  | 4 | **1.2.1.4.2.4 STANDS** |  | 2006-10-16 | 2013-08-30 |  |  |  |  |  |  |  |  |  |  |  |  |  |  |  |  |  |
| 121424005 |  | Develop Cartridge Design for Path Length Change (STANDS) | 45d | 2006-10-16 | 2006-12-19 | 9-070M FS+10d | 623d | 25d | MECH DES [69.6 h]; MECH ENG [34.8 h] | 5,234.62 | BEVINS M | 1 | 1 | MIKE B |  |  |  |  | 2006-12-19 | 07-003 | 1.2.1.4.2.4 |  |
| 121425005 |  | Dsgn of Modifed QR & QC/QB Girders (EXIST ARC Girders) | 50d | 2008-01-28 | 2008-04-07 | 9-080M FS+75d | 341d | 0d | MECH DES [240 h]; MECH ENG [80 h] | 15,142.4 | BEVINS M | 1 | 1 | MIKE B |  |  |  |  |  |  | 1.2.1.4.2.4 |  |
| 121425010 |  | Dsgn of simple QR Girder for H-B (EXIST ARC Girders)++ | 25d | 2008-04-08 | 2008-05-12 | 121425005 | 341d | 158d | MECH ENG [40 h]; MECH DES [120 h] | 7,571.2 | BEVINS M | 1 | 1 | MIKE B |  |  |  |  |  |  | 1.2.1.4.2.4 |  |
| 121424010 |  | New Stands for H-B Transport (EXIST ARC Stands)+ | 60d | 2008-12-24 | 2009-03-27 | 9-090M FS+58d | 125d | 0d | MECH DES [320 h]; MECH ENG [80 h] | 19,133.6 | BEVINS M | 1 | 1 | MIKE B |  |  |  |  |  |  | 1.2.1.4.2.4 | 07-027 |
| 121425015 |  | Pre-Constrctn Dsgn Review for Existing ARCs++ | 5d | 2009-03-30 | 2009-04-03 | 121424010, 121425010, 121421020 | 125d |  |  |  | BEVINS M | 1 | 1 | MIKE B |  |  |  |  |  |  | 1.2.1.4.2.4 | 07-027 |
| 121424015 |  | Re-Baseline Actuals Adjustment | 1d | 2013-08-30 | 2013-08-30 | 9-130M FS+227d | 20d |  | PROCUREMENT>$50K 69 NO ESCALATION | 12,344.88 | BEVINS M | 1 | 1 | MIKE B |  |  | 13-014 | ADJ |  |  |  |  |
|  | 5 | **1.2.1.4.2.5 GIRDERS** |  |  |  |  |  |  |  |  |  |  |  |  |  |  |  |  |  |  |  |  |
|  | 6 | **1.2.1.4.2.6 VACUUM** |  |  |  |  |  |  |  |  |  |  |  |  |  |  |  |  |  |  |  |  |
|  | 7 | **1.2.1.4.2.7 INSTALLATION** |  |  |  |  |  |  |  |  |  |  |  |  |  |  |  |  |  |  |  |  |
|  | 3 | **1.2.1.4.3 LINACS** |  | 2007-02-01 | 2013-08-30 |  |  |  |  |  |  |  |  |  |  |  |  |  |  |  |  |  |
|  | 1 | **1.2.1.4.3.1 QUADRUPOLES** |  |  |  |  |  |  |  |  |  |  |  |  |  |  |  |  |  |  |  |  |
|  | 2 | **1.2.1.4.3.2 CORRECTORS** |  | 2008-07-24 | 2013-08-30 |  |  |  |  |  |  |  |  |  |  |  |  |  |  |  |  |  |
| 121432005 |  | Final Dsgn of Linac Correctors & Skew Quads (Linac Correctors)++ | 30d | 2008-07-24 | 2008-09-04 | 9-080M FS+200d | 261d | 10d | MECH DES [120 h]; MECH ENG [80 h] | 10,044.8 | BEVINS M | 1 | 1 | MIKE B |  |  |  |  |  |  | 1.2.1.4.3.2 | 07-027 |
| 121432010 |  | Re-Baseline Actuals Adjustment | 1d | 2013-08-30 | 2013-08-30 | 9-130M FS+227d | 20d |  | PROCUREMENT>$50K 69 NO ESCALATION | 191.78 | BEVINS M | 1 | 1 | MIKE B |  |  | 13-014 | ADJ |  |  |  |  |
|  | 3 | **1.2.1.4.3.3 STANDS** |  | 2007-02-01 | 2013-08-30 |  |  |  |  |  |  |  |  |  |  |  |  |  |  |  |  |  |
| 121433005 |  | Initial layout of LINAC Stands and Girders (STANDS) | 85d | 2007-02-01 | 2007-06-01 | 9-070M FS+79d | 402d | 9d | MECH DES [139.2 h]; MECH ENG [69.6 h] | 10,436.08 | BEVINS M | 1 | 1 | MIKE B |  |  |  |  | 2007-06-01 | 07-003 | 1.2.1.4.3.3 |  |
| 121433908LOE |  | FY08 Mngmnt of Linac Stands | 248d | 2007-10-01 | 2008-09-30 | 121411007LOE, 9-080M | 20d | 0d |  |  | BEVINS M | 1 | 1 | MIKE B |  |  |  |  |  |  | 1.2.1.4.3.3 |  |
| 121434005 |  | Final Dsgn of Linac Girders (Linac Girders)++ | 40d | 2008-07-24 | 2008-09-18 | 9-080M FS+200d | 251d | 0d | MECH DES [120 h]; MECH ENG [120 h] | 12,518.4 | BEVINS M | 1 | 1 | MIKE B |  |  |  |  |  |  | 1.2.1.4.3.3 | 07-027 |
| 121434999 |  | Pre-Constrctn Dsgn Review for Linacs++ | 5d | 2008-09-19 | 2008-09-25 | 121432005, 121434005 | 251d |  |  |  | BEVINS M | 1 | 1 | MIKE B |  |  |  |  |  |  | 1.2.1.4.3.3 | 07-027 |
| 121433010 |  | Re-Baseline Actuals Adjustment | 1d | 2013-08-30 | 2013-08-30 | 9-130M FS+227d | 20d |  | PROCUREMENT>$50K 69 NO ESCALATION | 23,309.31 | BEVINS M | 1 | 1 | MIKE B |  |  | 13-014 | ADJ |  |  |  |  |

| ID | WBS | Activity | Type | Duration | Start | Finish | Predecessors | Total float | Free float | Resources | Cost | Planned FinishUDF | RESP - Responsibility | STRT%COMP for CM EVM | FNSH%COMP for CM EVM | WBS ASSIGNMENT | CAM RESPONSIBLE | CR 07-027 | EXPNS ACT BRIDGING FY SPLIT | CR 13-014 | ReBaseline Actuals Adjustment | Milestone Level | CR 08-058 |
| --- | --- | --- | --- | --- | --- | --- | --- | --- | --- | --- | --- | --- | --- | --- | --- | --- | --- | --- | --- | --- | --- | --- | --- |
|  | 4 | **1.2.1.4.3.4 GIRDERS** |  |  |  |  |  |  |  |  |  |  |  |  |  |  |  |  |  |  |  |  |  |
|  | 5 | **1.2.1.4.3.5 VACUUM** |  |  |  |  |  |  |  |  |  |  |  |  |  |  |  |  |  |  |  |  |  |
|  | 6 | **1.2.1.4.3.6 INSTALLATION** |  |  |  |  |  |  |  |  |  |  |  |  |  |  |  |  |  |  |  |  |  |
|  | 4 | **1.2.1.4.4 INJECTOR & RE-INJECTION** |  |  | 2007-02-02 | 2013-08-30 |  |  |  |  |  |  |  |  |  |  |  |  |  |  |  |  |  |
|  | 1 | **1.2.1.4.4.1 DIPOLES** |  |  | 2007-03-15 | 2013-08-30 |  |  |  |  |  |  |  |  |  |  |  |  |  |  |  |  |  |
| 121441005 |  | Develop Preliminary Design of Re-injection Dipoles (DIPOLES) |  | 65d | 2007-03-15 | 2007-06-14 | 9-070M FS+108d | 393d | 0d | MECH DES [69.6 h]; MECH ENG [104.4 h] | 9,522.9 | 2007-06-14 | BEVINS M | 1 | 1 | 1.2.1.4.4.1 | MIKE B |  |  |  |  |  |  |
| 121441010 |  | FY08 Final Dsgn of Re-injection Dipoles (INJ/RE-INJ Dipoles)++ |  | 48d | 2008-07-24 | 2008-09-30 | 9-080M FS+200d | 234d | 0d | MECH DES [320 h]; MECH ENG [96 h] | 19,530.24 |  | BEVINS M | 1 | 1 | 1.2.1.4.4.1 | MIKE B | 07-027 | EXP0809 |  |  |  |  |
| 121441010a |  | FY09 Final Dsgn of Re-injection Dipoles (INJ/RE-INJ Dipoles)++ |  | 12d | 2008-10-01 | 2008-10-16 | 121441010 | 234d | 0d | MECH DES [80 h]; MECH ENG [24 h] | 5,038.64 |  | BEVINS M | 1 | 1 | 1.2.1.4.4.1 | MIKE B | 07-027 | EXP0809 |  |  |  |  |
| 121441015 |  | Re-Baseline Actuals Adjustment |  | 1d | 2013-08-30 | 2013-08-30 | 9-130M FS+227d | 20d |  | PROCUREMENT>$50K 69 NO ESCALATION | 5,697.07 |  | BEVINS M | 1 | 1 |  | MIKE B |  |  | 13-014 | ADJ |  |  |
|  | 2 | **1.2.1.4.4.2 QUADRUPOLES** |  |  |  |  |  |  |  |  |  |  |  |  |  |  |  |  |  |  |  |  |  |
|  | 3 | **1.2.1.4.4.3 CORRECTORS** |  |  |  |  |  |  |  |  |  |  |  |  |  |  |  |  |  |  |  |  |  |
|  | 4 | **1.2.1.4.4.4 STANDS** |  |  | 2007-02-02 | 2013-08-30 |  |  |  |  |  |  |  |  |  |  |  |  |  |  |  |  |  |
| 121444005 |  | Develop Preliminary Layout & Stand Design |  | 90d | 2007-02-02 | 2007-06-11 | 9-070M FS+80d | 396d | 0d | MECH DES [208.8 h]; MECH ENG [139.2 h] | 17,805.15 | 2007-06-11 | BEVINS M | 1 | 1 | 1.2.1.4.4.4 | MIKE B |  |  |  |  |  |  |
| 121444010 |  | Preliminary Design & Safety Review of Layout & Stand Design |  | 20d | 2007-05-14 | 2007-06-11 | 121444005 FS-20d | 396d | 3d | MECH ENG [34.8 h]; MECH DES [34.8 h] | 3,680.79 | 2007-06-11 | BEVINS M | 1 | 1 | 1.2.1.4.4.4 | MIKE B |  |  |  |  |  |  |
| 121444010M |  | Re-Injection & Linac Preliminary Design & Safety Review Completed | milestone | 0d | 2007-06-14 | 2007-06-14 | 121444010, 121433005, 121441005 | 393d | 74d |  |  | 2007-06-14 | BEVINS M | 1 | 1 | 1.2.1.4.4.4 | MIKE B |  |  |  |  | 5 |  |
| 121444015 |  | Detailed Dsgn of Re-Injection Line & Stands (Injector & Re-Injection Stands) ++ |  | 85d | 2007-10-01 | 2008-02-08 | 9-080M, 121444010M | 319d | 0d | MECH ENG [320 h]; MECH DES [520 h] | 41,878.4 |  | BEVINS M | 1 | 1 | 1.2.1.4.4.4 | MIKE B |  |  |  |  |  |  |
| 121444020 |  | Detailed Dsgn of Spectrometer Move (Injector & Re-Injection Stands)++ |  | 90d | 2008-02-11 | 2008-06-17 | 121444015 | 319d | 85d | MECH DES [480 h]; MECH ENG [280 h] | 37,705.6 |  | BEVINS M | 1 | 1 | 1.2.1.4.4.4 | MIKE B |  |  |  |  |  |  |
| 13444909LOEXD |  | FY09 Mngmnt/Planning for Reinjection Modifications (INJ/RE-INJ Stands) |  | 59d | 2008-10-01 | 2008-12-24 | 121411908LOE, 9-090M | 20d | 0d | SR STAFF [47.58 h]; MECH DES [38.06 h] | 6,561.68 |  | BEVINS M | 1 | 1 |  | MIKE B |  |  |  |  |  | 08-058 |
| 121444025 |  | Re-Baseline Actuals Adjustment |  | 1d | 2013-08-30 | 2013-08-30 | 9-130M FS+227d | 20d |  | PROCUREMENT>$50K 69 NO ESCALATION | 25,366.41 |  | BEVINS M | 1 | 1 |  | MIKE B |  |  | 13-014 | ADJ |  |  |
|  | 5 | **1.2.1.4.4.5 GIRDERS** |  |  |  |  |  |  |  |  |  |  |  |  |  |  |  |  |  |  |  |  |  |
|  | 6 | **1.2.1.4.4.6 VACUUM** |  |  | 2008-07-31 | 2013-08-30 |  |  |  |  |  |  |  |  |  |  |  |  |  |  |  |  |  |
| 121446005 |  | Dsgn New Vac Chambers for Re-Injections (INJ/RE-INJ Vac)++ |  | 30d | 2008-07-31 | 2008-09-11 | 9-080M FS+205d | 259d | 25d | MECH ENG [20 h]; MECH DES [200 h] | 9,732.8 |  | BEVINS M | 1 | 1 | 1.2.1.4.4.6 | MIKE B | 07-027 |  |  |  |  |  |
| 121446999 |  | Pre-Constrctn Dsgn Review for Injector & Re-Injection+ |  | 2d | 2008-10-17 | 2008-10-20 | 121444015, 121444020, 121446005, 121441010a | 234d |  |  |  |  | BEVINS M | 1 | 1 | 1.2.1.4.4.6 | MIKE B | 07-027 |  |  |  |  |  |
| 121446010 |  | Re-Baseline Actuals Adjustment |  | 1d | 2013-08-30 | 2013-08-30 | 9-130M FS+227d | 20d |  | PROCUREMENT>$50K 69 NO ESCALATION | -9,733.4 |  | BEVINS M | 1 | 1 |  | MIKE B |  |  | 13-014 | ADJ |  |  |

| ID | WBS | Activity | Type | Duration | Start | Finish | Predecessors | Total float | Free float | Resources | Cost | Planned FinishUDF | RESP - Responsibility | STRT%COMP for CM EVM | FNSH%COMP for CM EVM | WBS ASSIGNMENT | CAM RESPONSIBLE | CR 07-027 | Milestone Level | CR 08-029 | CR 08-058 | CR 13-014 | ReBaseline Actuals Adjustment | CR 07-003 | ACT BRIDGING FY SPLIT | EXPNS ACT BRIDGING FY SPLIT |
| --- | --- | --- | --- | --- | --- | --- | --- | --- | --- | --- | --- | --- | --- | --- | --- | --- | --- | --- | --- | --- | --- | --- | --- | --- | --- | --- |
|  | 7 | **1.2.1.4.4.7 INSTALLATION** |  |  |  |  |  |  |  |  |  |  |  |  |  |  |  |  |  |  |  |  |  |  |  |  |
|  | 5 | **1.2.1.4.5 ARC 10 & HALL D BEAMLINE** |  |  | 2006-10-02 | 2013-08-30 |  |  |  |  |  |  |  |  |  |  |  |  |  |  |  |  |  |  |  |  |
|  | 1 | **1.2.1.4.5.1 DIPOLES** |  |  | 2006-10-02 | 2013-08-30 |  |  |  |  |  |  |  |  |  |  |  |  |  |  |  |  |  |  |  |  |
| 121451007LOE |  | FY07 Management of ARC 10 and Hall D (DIPOLES) |  | 247d | 2006-10-02 | 2007-09-28 | 9-070M | 20d | 0d | SUPPLIES & MATERIALS; MECH ENG [156.6 h]; SCIENTIST [139.2 h]; MECH TECH [69.6 h] | 41,767.61 | 2007-09-28 | BEVINS M | 1 | 1 | 1.2.1.4.5.1 | MIKE B |  |  |  |  |  |  |  |  |  |
| 121451020 |  | Develop Design of ARC 10 4m Dipole (DIPOLES) |  | 90d | 2006-10-02 | 2007-02-15 | 9-070M | 472d | 0d | MECH DES [348 h]; MECH ENG [208.8 h] | 28,322.33 | 2007-02-15 | BEVINS M | 1 | 1 | 1.2.1.4.5.1 | MIKE B | 07-027 |  |  |  |  |  |  |  |  |
| 121451025 |  | Preliminary Design & Safety Review of General Dipoles |  | 20d | 2007-01-19 | 2007-02-15 | 121451020 FS-20d | 472d | 0d | MECH DES [34.8 h]; MECH ENG [34.8 h] | 3,691.93 | 2007-02-15 | BEVINS M | 1 | 1 | 1.2.1.4.5.1 | MIKE B |  |  |  |  |  |  |  |  |  |
| 121451025M |  | General Dipole Design & Safety Review Completed | milestone | 0d | 2007-02-15 | 2007-02-15 | 121451025 | 472d | 0d |  |  | 2007-02-15 | BEVINS M | 1 | 1 | 1.2.1.4.5.1 | MIKE B |  | 5 |  |  |  |  |  |  |  |
| 121451030M |  | Finish Detailed Design of ARC 10 4m Dipole (DIPOLES)+ | milestone | 0d | 2007-04-27 | 2007-04-27 | 121451020 FS+50d, 121451025M FS+50d | 472d | 107d |  |  | 2007-02-15 | BEVINS M | 1 | 1 | 1.2.1.4.5.1 | MIKE B | 07-027 | 5 |  |  |  |  |  |  |  |
| 121451035 |  | Detailed Dsgn of 2m First bend Dipole (ARC 10/H-D Dipoles)++ |  | 50d | 2007-10-01 | 2007-12-11 | 9-080M, 121451030M | 401d | 150d | MECH ENG [280 h]; MECH DES [520 h] | 39,404.8 |  | BEVINS M | 1 | 1 | 1.2.1.4.5.1 | MIKE B |  |  |  |  |  |  |  |  |  |
| 121451040 |  | Modify Alignment Fixture (ARC 10/H-D Dipoles) |  | 20d | 2007-10-01 | 2007-10-26 | 9-080M | 471d | 220d |  |  |  | BEVINS M | 1 | 1 | 1.2.1.4.5.1 | MIKE B |  |  |  |  |  |  |  |  |  |
| 121451908LOE |  | FY08 Mngmnt of ARC 10 & H-D (ARC 10/H-D Dipoles) |  | 248d | 2007-10-01 | 2008-09-30 | 121451007LOE | 20d | 0d | MECH ENG [160 h]; MECH TECH [200 h]; SR STAFF [280 h]; SCIENTIST [160 h]; SUPPLIES & MATERIALS | 73,701.93 |  | BEVINS M | 1 | 1 | 1.2.1.4.5.1 | MIKE B |  |  |  |  |  |  |  |  |  |
| 121451909LOE |  | FY09 Mngmnt of ARC 10 & H-D (ARC 10/H-D Dipoles) |  | 248d | 2008-10-01 | 2009-09-30 | 121451908LOE | 20d | 0d | SR STAFF [280 h]; SCIENTIST [120 h] | 36,506.4 |  | BEVINS M | 1 | 1 | 1.2.1.4.5.1 | MIKE B |  |  |  |  |  |  |  |  |  |
| 13451055XD |  | Prcrmnt Prep of 4m Dipoles (ARC10/H-D Dipoles) |  | 59d | 2008-10-01 | 2008-12-24 | 9-090M, 121451030M | 117d | 0d | MECH ENG [42.91 h]; MECH DES [28.61 h] | 3,992.35 |  | BEVINS M | 1 | 1 |  | MIKE B |  |  | 08-029 | 08-058 |  |  |  |  |  |
| 13451909LOEXD |  | FY09 Mngmnt & Oversight (ARC10/H-D Dipoles) |  | 59d | 2008-10-01 | 2008-12-24 | 121451908LOE | 20d | 0d | TRAVEL; SR STAFF [47.58 h] | 6,580.27 |  | BEVINS M | 1 | 1 |  | MIKE B |  |  |  | 08-058 |  |  |  |  |  |
| 121451060 |  | Re-Baseline Actuals Adjustment |  | 1d | 2013-08-30 | 2013-08-30 | 9-130M FS+227d | 20d |  | PROCUREMENT>$50K 69 NO ESCALATION | 51,885.59 |  | BEVINS M | 1 | 1 |  | MIKE B |  |  |  |  | 13-014 | ADJ |  |  |  |
|  | 2 | **1.2.1.4.5.2 QUADRUPOLES** |  |  | 2006-12-05 | 2013-08-30 |  |  |  |  |  |  |  |  |  |  |  |  |  |  |  |  |  |  |  |  |
| 121452005 |  | Develop Preliminary Design of New Quadrupoles |  | 110d | 2006-12-05 | 2007-05-17 | 9-070M FS+44d | 343d | 0d | MECH ENG [208.8 h]; MECH DES [208.8 h] | 22,130.94 | 2007-05-17 | BEVINS M | 1 | 1 | 1.2.1.4.5.2 | MIKE B |  |  |  |  |  |  |  |  |  |
| 121452010 |  | Preliminary Design & Safety Review of Quads |  | 20d | 2007-04-20 | 2007-05-17 | 121452005 FS-20d | 343d | 0d | MECH DES [34.8 h]; MECH ENG [34.8 h] | 3,680.79 | 2007-05-17 | BEVINS M | 1 | 1 | 1.2.1.4.5.2 | MIKE B |  |  |  |  |  |  |  |  |  |
| 121452010M |  | Preliminary Quad Design & Safety Review Completed | milestone | 0d | 2007-05-17 | 2007-05-17 | 121452010, 121452005 | 343d | 0d |  |  | 2007-05-17 | BEVINS M | 1 | 1 | 1.2.1.4.5.2 | MIKE B |  | 5 |  |  |  |  |  |  |  |
| 121452015 |  | Develop Detailed Design of New Quadrupoles (QUAD POLES) |  | 90d | 2007-05-18 | 2007-09-25 | 121452010M | 343d | 0d | MECH DES [417.6 h]; MECH ENG [174 h] | 28,099.44 | 2007-09-25 | BEVINS M | 1 | 1 | 1.2.1.4.5.2 | MIKE B |  |  |  |  |  |  |  |  |  |
| 121452020M |  | New Quad Designs Complete (QUAD POLES)++ | milestone | 0d | 2007-09-25 | 2007-09-25 | 121452015 | 343d | 3d |  |  | 2007-09-25 | BEVINS M | 1 | 1 | 1.2.1.4.5.2 | MIKE B |  | 5 |  |  |  |  |  |  |  |
| 13452025X |  | Prcrmnt Prep for Quads (ARC 10/H-D Q-POLES) |  | 59d | 2008-10-01 | 2008-12-24 | 9-090M, 121452020M | 92d | 0d | MECH DES [51.87 h]; MECH ENG [51.87 h] | 5,583.8 |  | BEVINS M | 1 | 1 |  | MIKE B |  |  | 08-029 | 08-058 |  |  |  |  |  |
| 121452025 |  | Re-Baseline Actuals Adjustment |  | 1d | 2013-08-30 | 2013-08-30 | 9-130M FS+227d | 20d |  | PROCUREMENT>$50K 69 NO ESCALATION | 108,652.09 |  | BEVINS M | 1 | 1 |  | MIKE B |  |  |  |  | 13-014 | ADJ |  |  |  |
|  | 3 | **1.2.1.4.5.3 CORRECTORS** |  |  |  |  |  |  |  |  |  |  |  |  |  |  |  |  |  |  |  |  |  |  |  |  |
|  | 4 | **1.2.1.4.5.4 STANDS** |  |  | 2006-12-05 | 2013-08-30 |  |  |  |  |  |  |  |  |  |  |  |  |  |  |  |  |  |  |  |  |
| 121454005 |  | Develop Preliminary Design of Arc 10 and Hall D Layout (STANDS) |  | 110d | 2006-12-05 | 2007-05-17 | 9-070M FS+44d | 401d | 0d | MECH DES [417.6 h]; MECH ENG [208.8 h] | 31,348.32 | 2007-05-17 | BEVINS M | 1 | 1 | 1.2.1.4.5.4 | MIKE B |  |  |  |  |  |  | 07-003 |  |  |
| 121455000M |  | Begin Arc 10 and Hall D Girder Designs (GIRDERS) | milestone | 0d | 2007-03-01 | 2007-03-01 | 9-070M FS+98d | 414d | 0d |  |  | 2007-03-01 | BEVINS M | 1 | 1 | 1.2.1.4.5.4 | MIKE B |  | 6 |  |  |  |  | 07-003 |  |  |
| 121455005 |  | Preliminary Design Arc 10 & Hall D Quad Girders (GIRDERS) |  | 43d | 2007-03-01 | 2007-04-30 | 121455000M | 414d | 13d | MECH ENG [48.8 h]; MECH DES [137.6 h] | 9,080.05 | 2007-04-30 | BEVINS M | 1 | 1 | 1.2.1.4.5.4 | MIKE B |  |  |  |  |  |  | 07-003 |  |  |
| 121454010 |  | Preliminary Design & Safety Review of Arc 10 and Hall D Layout (STANDS) |  | 20d | 2007-04-20 | 2007-05-17 | 121454005 FS-20d | 401d | 0d | MECH DES [34.8 h]; MECH ENG [34.8 h] | 3,680.79 | 2007-05-17 | BEVINS M | 1 | 1 | 1.2.1.4.5.4 | MIKE B |  |  |  |  |  |  | 07-003 |  |  |
| 121454010M |  | Preliminary Design & Safety Review of Arc 10 and Hall D Layout Completed | milestone | 0d | 2007-05-17 | 2007-05-17 | 121454005, 121454010, 121455005, 121456005 | 401d | 0d |  |  | 2007-05-17 | BEVINS M | 1 | 1 | 1.2.1.4.5.4 | MIKE B |  | 5 |  |  |  |  | 07-003 |  |  |
| 121455006 |  | FY07 Phase of Final Design Arc 10 & Hall D Quad Girders (GIRDERS) |  | 93d | 2007-05-18 | 2007-09-28 | 121454010M | 401d | 0d | MECH DES [280 h]; MECH ENG [160 h] | 21,456.74 | 2007-09-28 | BEVINS M | 1 | 1 | 1.2.1.4.5.4 | MIKE B |  |  |  |  |  |  | 07-003 |  |  |
| 121454015 |  | FY08 Detailed Dsgn of ARC 10 Stands++ |  | 248d | 2007-10-01 | 2008-09-30 | 9-080M | 146d | 0d | MECH ENG [1218.74 h]; MECH DES [1728.91 h]; PLABOR | 172,208.58 |  | BEVINS M | 1 | 1 | 1.2.1.4.5.4 | MIKE B |  |  |  |  |  |  |  | FY08-09 | EXP0809 |
| 121455010 |  | Final Dsgn H-D & Arc 10 Quad Girders (IARC 10/H-D Girders) |  | 90d | 2007-10-01 | 2008-02-15 | 121452020M, 121455006, 9-080M | 401d | 0d | MECH DES [480 h]; MECH ENG [240 h] | 35,232 |  | BEVINS M | 1 | 1 | 1.2.1.4.5.4 | MIKE B |  |  |  |  |  |  |  |  |  |
| 121455015M |  | Finish H-D & Arc 10 Girders (IARC 10/H-D GIRDERS)++ | milestone | 0d | 2008-02-15 | 2008-02-15 | 121455010 | 401d | 150d |  |  |  | BEVINS M | 1 | 1 | 1.2.1.4.5.4 | MIKE B |  | 6 |  |  |  |  |  |  |  |
| 121454015a |  | FY09 Detailed Dsgn of ARC 10 Stands++ |  | 102d | 2008-10-01 | 2009-03-05 | 121454015 | 146d | 90d | MECH ENG [501.26 h]; MECH DES [711.09 h]; PLABOR | 73,089.77 |  | BEVINS M | 1 | 1 | 1.2.1.4.5.4 | MIKE B |  |  |  |  |  |  |  | FY08-09 | EXP0809 |
| 121454020 |  | Re-Baseline Actuals Adjustment |  | 1d | 2013-08-30 | 2013-08-30 | 9-130M FS+227d | 20d |  | PROCUREMENT>$50K 69 NO ESCALATION | 174,877.85 |  | BEVINS M | 1 | 1 |  | MIKE B |  |  |  |  | 13-014 | ADJ |  |  |  |

Notes:
- 121454015: Corrective Actions: Changed Purchased labor from $20K to $32K based on input from LH 050907 - / RKC / From MWiseman Rev B -2.xls
- 121454015a: Corrective Actions: Changed Purchased labor from $20K to $32K based on input from LH 050907 - / RKC / From MWiseman Rev B -2.xls

| ID | WBS | Activity | Type | Duration | Start | Finish | Predecessors | Total float | Free float | Resources | Cost | Planned FinishUDF | RESP - Responsibility | STRT%COMP for CM EVM | FNSH%COMP for CM EVM | WBS ASSIGNMENT | CAM RESPONSIBLE | CR 07-027 | CR 13-014 | ReBaseline Actuals Adjustment | CR 11-028 | Milestone Level | CR 08-058 |
| --- | --- | --- | --- | --- | --- | --- | --- | --- | --- | --- | --- | --- | --- | --- | --- | --- | --- | --- | --- | --- | --- | --- | --- |
|  | 5 | **1.2.1.4.5.5 GIRDERS** |  |  |  |  |  |  |  |  |  |  |  |  |  |  |  |  |  |  |  |  |  |
|  | 6 | **1.2.1.4.5.6 VACUUM** |  |  | 2007-04-02 | 2013-08-30 |  |  |  |  |  |  |  |  |  |  |  |  |  |  |  |  |  |
| 121456005 |  | PreliminaryDesign 4m Dipole Chambers (VACUUM) |  | 25d | 2007-04-02 | 2007-05-04 | 9-070M FS+120d | 410d | 9d | MECH ENG [20.88 h] | 1,295.4 | 2007-05-04 | BEVINS M | 1 | 1 | 1.2.1.4.5.6 | MIKE B |  |  |  |  |  |  |
| 121456010 |  | Detail Design 4m Dipole Chambers (VACUUM) |  | 46d | 2007-05-18 | 2007-07-24 | 121454010M | 498d | 247d | MECH ENG [34.8 h]; MECH DES [69.6 h] | 5,115.11 | 2007-07-16 | BEVINS M | 1 | 1 | 1.2.1.4.5.6 | MIKE B | 07-027 |  |  |  |  |  |
| 121456015 |  | Dsgn 2m Dipole Chamb for First bend (ARC 10 & H-D Vac)++ |  | 40d | 2008-07-24 | 2008-09-18 | 9-080M FS+200d, 121451035, 121456010 | 251d | 0d | MECH DES [80 h]; MECH ENG [40 h] | 5,872 |  | BEVINS M | 1 | 1 | 1.2.1.4.5.6 | MIKE B | 07-027 |  |  |  |  |  |
| 121456999 |  | Pre-Constrctn Dsgn Review (ARC 10 & H-D)++ |  | 5d | 2008-09-19 | 2008-09-25 | 121454015a FS-200d, 121456015, 121451040, 121455015M, 121451035, 9-080M FS-270d | 251d | 68d |  |  |  | BEVINS M | 1 | 1 | 1.2.1.4.5.6 | MIKE B | 07-027 |  |  |  |  |  |
| 121456020 |  | Re-Baseline Actuals Adjustment |  | 1d | 2013-08-30 | 2013-08-30 | 9-130M FS+227d | 20d |  | PROCUREMENT>$50K 69 NO ESCALATION | 204.5 |  | BEVINS M | 1 | 1 |  | MIKE B |  | 13-014 | ADJ |  |  |  |
|  | 7 | **1.2.1.4.5.7 LCW & INSTRUMENT AIR** |  |  |  |  |  |  |  |  |  |  |  |  |  |  |  |  |  |  |  |  |  |
|  | 8 | **1.2.1.4.5.8 INSTALLATION** |  |  |  |  |  |  |  |  |  |  |  |  |  |  |  |  |  |  |  |  |  |
|  | 6 | **1.2.1.4.6 INJECTOR RECIRCULATION** |  |  |  |  |  |  |  |  |  |  |  |  |  |  |  |  |  |  |  |  |  |
|  | 1 | **1.2.1.4.6.1 DIPOLES** |  |  |  |  |  |  |  |  |  |  |  |  |  |  |  |  |  |  |  |  |  |
|  | 2 | **1.2.1.4.6.2 QUADRUPOLES** |  |  |  |  |  |  |  |  |  |  |  |  |  |  |  |  |  |  |  |  |  |
|  | 3 | **1.2.1.4.6.3 CORRECTORS** |  |  |  |  |  |  |  |  |  |  |  |  |  |  |  |  |  |  |  |  |  |
|  | 4 | **1.2.1.4.6.4 STANDS** |  |  |  |  |  |  |  |  |  |  |  |  |  |  |  |  |  |  |  |  |  |
|  | 5 | **1.2.1.4.6.5 GIRDERS** |  |  |  |  |  |  |  |  |  |  |  |  |  |  |  |  |  |  |  |  |  |
|  | 6 | **1.2.1.4.6.6 VACUUM** |  |  |  |  |  |  |  |  |  |  |  |  |  |  |  |  |  |  |  |  |  |
|  | 7 | **1.2.1.4.6.7 INSTALLATION** |  |  |  |  |  |  |  |  |  |  |  |  |  |  |  |  |  |  |  |  |  |
|  | 5 | **1.2.1.5 EXTRACTION** |  |  | 2006-10-02 | 2013-08-30 |  |  |  |  |  |  |  |  |  |  |  |  |  |  |  |  |  |
|  | 1 | **1.2.1.5.1 CAVITIES** |  |  | 2006-10-02 | 2013-08-30 |  |  |  |  |  |  |  |  |  |  |  |  |  |  |  |  |  |
| 12151007LOE |  | FY07 Management of Extraction WBS (CAVITIES) |  | 247d | 2006-10-02 | 2007-09-28 | 9-070M | 148d | 0d | SCIENTIST [382.8 h] | 24,132.04 | 2007-09-28 | SPATA M | 1 | 1 | 1.2.1.5.1 | MIKE S |  |  |  | 11-028 |  |  |
| 12151009 |  | Develop Design Package for Cavities (CAVITIES) |  | 25d | 2006-11-01 | 2006-12-07 | 9-070M FS+22d | 673d | 0d | ELEC ENG [83.52 h]; MECH ENG [83.52 h] | 10,676.37 | 2006-12-07 | SPATA M | 1 | 1 | 1.2.1.5.1 | MIKE S |  |  |  |  |  |  |
| 12151010 |  | Design & Safety Review for Cavity Package (CAVITIES) |  | 1d | 2006-12-08 | 2006-12-08 | 12151009 | 673d | 0d | MECH ENG [6.96 h]; ELEC ENG [6.96 h] | 889.7 | 2006-12-08 | SPATA M | 1 | 1 | 1.2.1.5.1 | MIKE S |  |  |  |  |  |  |
| 12151015 |  | Post-review development of Design Package for Cavities (CAVITIES) |  | 22d | 2006-12-11 | 2007-01-18 | 12151010 | 673d | 0d | SKLLD TRADE [34.8 h]; MECH ENG [13.92 h]; ELEC ENG [13.92 h] | 2,818.52 | 2006-12-22 | SPATA M | 1 | 1 | 1.2.1.5.1 | MIKE S | 07-027 |  |  |  |  |  |
| 12151020M |  | Finish Design of RF Cavities (CAVITIES) | milestone | 0d | 2007-01-18 | 2007-01-18 | 12151015 | 673d |  |  |  | 2006-12-22 | SPATA M | 1 | 1 | 1.2.1.5.1 | MIKE S |  |  |  |  | 5 |  |
| 12151908LOE |  | FY08 Mngmnt of Extraction WBS |  | 248d | 2007-10-01 | 2008-09-30 | 12151007LOE | 148d | 0d | SCIENTIST [616 h] | 38,358.32 |  | SPATA M | 1 | 1 | 1.2.1.5.1 | MIKE S |  |  |  | 11-028 |  |  |
| 1351909LOEX |  | FY09 Mngmnt Oversight (Cavities) |  | 59d | 2008-10-01 | 2008-12-24 | 9-090M | 20d | 0d | TRAVEL; SCIENTIST [132.27 h] | 9,386.3 |  | SPATA M | 1 | 1 |  | MIKE S |  |  |  |  |  | 08-058 |
| 12151025 |  | Re-Baseline Actuals Adjustment |  | 1d | 2013-08-30 | 2013-08-30 | 9-130M FS+227d | 20d |  | PROCUREMENT>$50K 69 NO ESCALATION | -23,596.84 |  | SPATA M | 1 | 1 |  | MIKE S |  | 13-014 | ADJ |  |  |  |

Notes:
- 12151908LOE: Entry Criteria: Ext Pred: / 12151025LOE

| ID | WBS | Activity | Type | Duration | Start | Finish | Predecessors | Total float | Free float | Resources | Cost | Planned FinishUDF | RESP - Responsibility | STRT%COMP for CM EVM | FNSH%COMP for CM EVM | WBS ASSIGNMENT | CAM RESPONSIBLE | CR 07-027 | Milestone Level | CR 13-014 | ReBaseline Actuals Adjustment | CR 08-058 | CR 11-028 | CR 09-012 |
| --- | --- | --- | --- | --- | --- | --- | --- | --- | --- | --- | --- | --- | --- | --- | --- | --- | --- | --- | --- | --- | --- | --- | --- | --- |
|  | 2 | **1.2.1.5.2 RF COMPONENTS** |  |  | 2007-02-14 | 2013-08-30 |  |  |  |  |  |  |  |  |  |  |  |  |  |  |  |  |  |  |
| 12152005 |  | Develop design package for RF Components (RF COMPON) |  | 30d | 2007-02-14 | 2007-03-28 | 9-070M FS+88d | 573d | 0d | ELEC DES [55.68 h]; ELEC ENG [83.52 h] | 8,022.66 | 2007-03-28 | SPATA M | 1 | 1 | 1.2.1.5.2 | MIKE S |  |  |  |  |  |  |  |
| 12152010 |  | Design & Safety Review for RF Components (RF COMPON) |  | 1d | 2007-03-29 | 2007-03-29 | 12152005 | 573d | 0d | ELEC ENG [6.96 h]; ELEC DES [6.96 h] | 772.91 | 2007-03-29 | SPATA M | 1 | 1 | 1.2.1.5.2 | MIKE S |  |  |  |  |  |  |  |
| 12152015 |  | Post-review development of Design Package for RF Components (RF COMPON) |  | 16d | 2007-03-30 | 2007-04-20 | 12152010 | 573d | 112d | ELEC DES [6.96 h]; ELEC ENG [13.92 h] | 1,181.21 | 2007-04-12 | SPATA M | 1 | 1 | 1.2.1.5.2 | MIKE S | 07-027 |  |  |  |  |  |  |
| 12152025 |  | Continue Dsgn Package for RF Compnts (RF COMPON) |  | 30d | 2007-10-01 | 2007-11-09 | 12152015, 9-080M | 461d | 0d | ELEC ENG [80 h]; ELEC DES [80 h] | 8,543.2 |  | SPATA M | 1 | 1 | 1.2.1.5.2 | MIKE S |  |  |  |  |  |  |  |
| 12152030M |  | Comp Dsgn for RF Components++ | milestone | 0d | 2007-11-09 | 2007-11-09 | 12152025 | 461d | 346d |  |  |  | SPATA M | 1 | 1 | 1.2.1.5.2 | MIKE S |  | 6 |  |  |  |  |  |
| 12152035 |  | Re-Baseline Actuals Adjustment |  | 1d | 2013-08-30 | 2013-08-30 | 9-130M FS+227d | 20d |  | PROCUREMENT>$50K 69 NO ESCALATION | -16,739.32 |  | SPATA M | 1 | 1 |  | MIKE S |  |  | 13-014 | ADJ |  |  |  |
|  | 3 | **1.2.1.5.3 RESONANCE CONTROL** |  |  | 2006-10-02 | 2013-08-30 |  |  |  |  |  |  |  |  |  |  |  |  |  |  |  |  |  |  |
| 12153005 |  | Determine and checkout LCW capacity (RESON CNTRL) |  | 5d | 2006-10-02 | 2006-10-06 | 9-070M | 727d | 28d | PLANT ENG [17.4 h] | 1,088.2 | 2006-10-06 | SPATA M | 1 | 1 | 1.2.1.5.3 | MIKE S |  |  |  |  |  |  |  |
| 12153010 |  | Develop Design Package for Resonance Control (RESON CNTRL) |  | 30d | 2006-10-02 | 2006-11-10 | 9-070M | 699d | 0d | MECH DES [48.72 h]; ELEC ENG [104.4 h]; ELEC DES [104.4 h]; ELEC TECH [62.64 h] | 16,347.93 | 2006-11-10 | SPATA M | 1 | 1 | 1.2.1.5.3 | MIKE S |  |  |  |  |  |  |  |
| 12153015 |  | Design & Safety Review for Resonance Control (RESON CNTRL) |  | 1d | 2006-11-16 | 2006-11-16 | 12153010 FS+3d, 12153005 | 699d | 0d | ELEC ENG [6.96 h]; ELEC DES [6.96 h]; MECH DES [6.96 h] | 1,081.45 | 2006-11-13 | SPATA M | 1 | 1 | 1.2.1.5.3 | MIKE S | 07-027 |  |  |  |  |  |  |
| 12153020 |  | Post-review development of Design Package for Resonance Control (RESON CNTRL) |  | 5d | 2006-11-17 | 2006-11-27 | 12153015 | 699d | 0d | ELEC TECH [6.96 h]; ELEC DES [27.84 h]; MECH DES [13.92 h]; ELEC ENG [27.84 h] | 3,996.98 | 2006-11-29 | SPATA M | 1 | 1 | 1.2.1.5.3 | MIKE S | 07-027 |  |  |  |  |  |  |
| 12153025M |  | Finish Resonance Control Design (RESON CNTRL) | milestone | 0d | 2006-11-27 | 2006-11-27 | 12153020 | 699d | 584d |  |  | 2006-11-29 | SPATA M | 1 | 1 | 1.2.1.5.3 | MIKE S |  | 5 |  |  |  |  |  |
| 12153025 |  | Re-Baseline Actuals Adjustment |  | 1d | 2013-08-30 | 2013-08-30 | 9-130M FS+227d | 20d |  | PROCUREMENT>$50K 69 NO ESCALATION | -11,841.47 |  | SPATA M | 1 | 1 |  | MIKE S |  |  | 13-014 | ADJ |  |  |  |
|  | 4 | **1.2.1.5.4 LAMBERTSON** |  |  | 2007-03-15 | 2013-08-30 |  |  |  |  |  |  |  |  |  |  |  |  |  |  |  |  |  |  |
| 12154005 |  | Develop Design Package for Lambertson (LAMBERTSON) |  | 50d | 2007-03-15 | 2007-05-23 | 9-070M FS+108d | 564d | 0d | MECH ENG [132.4 h]; MECH DES [122 h] | 13,557.83 | 2007-05-23 | SPATA M | 1 | 1 | 1.2.1.5.4 | MIKE S |  |  |  |  |  |  |  |
| 12154010 |  | Design & Safety Review for Lambertson (LAMBERTSON) |  | 1d | 2007-05-24 | 2007-05-24 | 12154005 | 564d | 0d | MECH ENG [41.6 h]; MECH DES [146 h] | 8,965.44 | 2007-05-24 | SPATA M | 1 | 1 | 1.2.1.5.4 | MIKE S |  |  |  |  |  |  |  |
| 12154015 |  | Post-review development of Design Package for Lambertson (LAMBERTSON) |  | 15d | 2007-05-25 | 2007-06-15 | 12154010 | 564d | 0d | MECH DES [45.24 h]; MECH ENG [34.8 h] | 4,137.34 | 2007-06-15 | SPATA M | 1 | 1 | 1.2.1.5.4 | MIKE S |  |  |  |  |  |  |  |
| 12154020M |  | Finished Lambertson Design (LAMBERTSON) | milestone | 0d | 2007-06-15 | 2007-06-15 | 12154015 | 564d | 449d |  |  | 2007-06-15 | SPATA M | 1 | 1 | 1.2.1.5.4 | MIKE S |  | 5 |  |  |  |  |  |
| 1354909LOEX |  | FY09 Engrng Oversight (LAMBERTSON) |  | 59d | 2008-10-01 | 2008-12-24 | 12151908LOE | 148d | 0d | MECH ENG [19.03 h]; TRAVEL | 1,974.27 |  | SPATA M | 1 | 1 |  | MIKE S |  |  |  |  | 08-058 | 11-028 |  |
| 12154025 |  | Re-Baseline Actuals Adjustment |  | 1d | 2013-08-30 | 2013-08-30 | 9-130M FS+227d | 20d |  | PROCUREMENT>$50K 69 NO ESCALATION | 12,642.91 |  | SPATA M | 1 | 1 |  | MIKE S |  |  | 13-014 | ADJ |  |  |  |
|  | 5 | **1.2.1.5.5 SEPTA & DIPOLES** |  |  | 2007-02-13 | 2013-08-30 |  |  |  |  |  |  |  |  |  |  |  |  |  |  |  |  |  |  |
| 12155005 |  | Develop Design Package for Septa and Dipoles (SEPTA/DIPOLES) |  | 75d | 2007-02-13 | 2007-05-30 | 9-070M FS+87d | 424d | 0d | MECH ENG [215.76 h] | 13,359.17 | 2007-05-30 | SPATA M | 1 | 1 | 1.2.1.5.5 | MIKE S |  |  |  |  |  |  |  |
| 12155006 |  | Preliminary Design & Safety Review for Septa and Dipoles (SEPTA/DIPOLES) |  | 1d | 2007-05-31 | 2007-05-31 | 12155005 | 424d | 0d | MECH ENG [6.96 h] | 431.8 | 2007-05-31 | SPATA M | 1 | 1 | 1.2.1.5.5 | MIKE S |  |  |  |  |  |  |  |
| 12155007 |  | Post-review development of Design Package for Septa and dipoles (SEPTA/DIPOLES) |  | 10d | 2007-06-01 | 2007-06-14 | 12155006 | 424d | 74d | MECH ENG [20.88 h] | 1,295.4 | 2007-06-14 | SPATA M | 1 | 1 | 1.2.1.5.5 | MIKE S |  |  |  |  |  |  |  |
| 12155035 |  | Dsgn Septa & Dipoles |  | 90d | 2007-10-01 | 2008-02-15 | 12155007, 9-080M | 350d | 0d | MECH DES [92 h]; MECH ENG [136 h] | 12,318.4 |  | SPATA M | 1 | 1 | 1.2.1.5.5 | MIKE S |  |  |  |  |  |  | 09-012 |
| 12155908LOE |  | FY08 Oversee Dsgn Package for Septa & Dipoles |  | 248d | 2007-10-01 | 2008-09-30 | 9-080M | 20d | 0d | MECH ENG [72 h] | 4,452.48 |  | SPATA M | 1 | 1 | 1.2.1.5.5 | MIKE S |  |  |  |  |  |  |  |
| 12155040 |  | Prelim Dsgn Review for Septa & Dipoles |  | 1d | 2008-02-19 | 2008-02-19 | 12155035 | 350d | 0d | MECH ENG [8 h]; MECH DES [8 h] | 834.56 |  | SPATA M | 1 | 1 | 1.2.1.5.5 | MIKE S |  |  |  |  |  |  |  |
| 12155045 |  | Post-Review Development of Dsgn Package for Septa & Dipoles |  | 50d | 2008-02-20 | 2008-04-29 | 12155040 | 350d | 0d | MECH ENG [76 h]; MECH DES [68 h] | 7,588.48 |  | SPATA M | 1 | 1 | 1.2.1.5.5 | MIKE S |  |  |  |  |  |  | 09-012 |
| 12155050M |  | End of Extraction Septa & Dipole PED Effort+ | milestone | 0d | 2008-04-29 | 2008-04-29 | 12155045 | 350d | 235d |  |  |  | SPATA M | 1 | 1 | 1.2.1.5.5 | MIKE S |  | 6 |  |  |  |  |  |
| 12155055 |  | Re-Baseline Actuals Adjustment |  | 1d | 2013-08-30 | 2013-08-30 | 9-130M FS+227d | 20d |  | PROCUREMENT>$50K 69 NO ESCALATION | 29,184.73 |  | SPATA M | 1 | 1 |  | MIKE S |  |  | 13-014 | ADJ |  |  |  |

| ID | WBS | Activity | Type | Duration | Start | Finish | Predecessors | Total float | Free float | Resources | Cost | Planned FinishUDF | RESP - Responsibility | STRT%COMP for CM EVM | FNSH%COMP for CM EVM | WBS ASSIGNMENT | CAM RESPONSIBLE | CR 07-027 | Ties | CR 08-003 | EXPNS ACT BRIDGING FY SPLIT | ACT BRIDGING FY SPLIT | Milestone Level | CR 13-014 | ReBaseline Actuals Adjustment | CR 09-012 | Profile change | CR 08-058 |
| --- | --- | --- | --- | --- | --- | --- | --- | --- | --- | --- | --- | --- | --- | --- | --- | --- | --- | --- | --- | --- | --- | --- | --- | --- | --- | --- | --- | --- |
|  | 6 | **1.2.1.5.6 STANDS** |  |  | 2006-11-01 | 2013-08-30 |  |  |  |  |  |  |  |  |  |  |  |  |  |  |  |  |  |  |  |  |  |  |
| 12156005 |  | Develop Design Package for Stands (STANDS) |  | 80d | 2006-11-01 | 2007-03-06 | 9-070M FS+22d | 185d | 0d | MECH DES [320.16 h]; MECH ENG [139.2 h] | 22,789.68 | 2007-03-06 | SPATA M | 1 | 1 | 1.2.1.5.6 | MIKE S |  |  |  |  |  |  |  |  |  |  |  |
| 12156010 |  | Preliminary Design & Safety Review for Stands (STANDS) |  | 1d | 2007-03-07 | 2007-03-07 | 12156005 | 185d | 0d | MECH ENG [6.96 h] | 429.85 | 2007-03-07 | SPATA M | 1 | 1 | 1.2.1.5.6 | MIKE S |  |  |  |  |  |  |  |  |  |  |  |
| 12156015 |  | Post-review development of Design Package for Stands (STANDS) |  | 20d | 2007-03-08 | 2007-04-04 | 12156010 | 185d | 124d | MECH ENG [34.8 h]; MECH DES [56 h] | 4,628.15 | 2007-04-04 | SPATA M | 1 | 1 | 1.2.1.5.6 | MIKE S |  |  |  |  |  |  |  |  |  |  |  |
| 12156000 |  | FY08 Expenses |  | 248d | 2007-10-01 | 2008-09-30 | 9-080M | 0d |  | SUPPLIES & MATERIALS; TRAVEL | 10,927.82 |  | SPATA M | 1 | 1 | 1.2.1.5.6 | MIKE S | 07-027 | Spata | 08-003 |  |  |  |  |  |  |  |  |
| 12156030 |  | FY08 Develop Dsgn Package for Stands |  | 248d | 2007-10-01 | 2008-09-30 | 12156015, 9-080M | 61d | 0d | MECH ENG [440.89 h]; MECH DES [1047.11 h] | 71,745.87 |  | SPATA M | 1 | 1 | 1.2.1.5.6 | MIKE S | 07-027 |  |  | EXP0809 |  |  |  |  |  |  |  |
| 12156002 |  | FY09 Expenses |  | 248d | 2008-10-01 | 2009-09-30 | 12156000 | 0d |  | SUPPLIES & MATERIALS; TRAVEL | 11,276.42 |  | SPATA M | 1 | 1 | 1.2.1.5.6 | MIKE S | 07-027 | Spata | 08-003 |  |  |  |  |  |  |  |  |
| 12156030a |  | FY09 Develop Dsgn Package for Stands |  | 112d | 2008-10-01 | 2009-03-19 | 12156030 | 61d | 13d | MECH DES [472.89 h]; MECH ENG [199.11 h] | 33,436.71 |  | SPATA M | 1 | 1 | 1.2.1.5.6 | MIKE S | 07-027 |  |  | EXP0809 |  |  |  |  |  |  |  |
| 12156035 |  | Finalize Dsgn Package for Stands |  | 75d | 2009-04-08 | 2009-07-23 | 9-090M FS+125d, 12156030a | 48d | 0d | MECH DES [320 h]; MECH ENG [200 h] | 26,790.8 |  | SPATA M | 1 | 1 | 1.2.1.5.6 | MIKE S | 07-027 |  |  |  | FY08-09 |  |  |  |  |  |  |
| 12156040M |  | Stands Dsgn Comp++ | milestone | 0d | 2009-04-13 | 2009-04-13 | 12156035 FS-72d | 115d | 0d |  |  |  | SPATA M | 1 | 1 | 1.2.1.5.6 | MIKE S | 07-027 |  |  |  |  | 6 |  |  |  |  |  |
| 12156045 |  | Pre-Constrctn Dsgn Review for Extraction++ |  | 5d | 2009-04-13 | 2009-04-17 | 12156040M, 12153025M, 12154020M, 12152030M, 12155050M | 115d |  |  |  |  | SPATA M | 1 | 1 | 1.2.1.5.6 | MIKE S | 07-027 |  |  |  |  |  |  |  |  |  |  |
| 12156050 |  | Re-Baseline Actuals Adjustment |  | 1d | 2013-08-30 | 2013-08-30 | 9-130M FS+227d | 20d |  | PROCUREMENT>$50K 69 NO ESCALATION | 56,453.13 |  | SPATA M | 1 | 1 |  | MIKE S |  |  |  |  |  |  | 13-014 | ADJ |  |  |  |
|  | 6 | **1.2.1.6 INSTRUMENTATION, CONTROLS, & SAFETY SYSTEMS** |  |  | 2006-10-02 | 2013-08-30 |  |  |  |  |  |  |  |  |  |  |  |  |  |  |  |  |  |  |  |  |  |  |
|  | 1 | **1.2.1.6.1 BEAM DIAGNOSTICS** |  |  | 2006-10-02 | 2013-08-30 |  |  |  |  |  |  |  |  |  |  |  |  |  |  |  |  |  |  |  |  |  |  |
|  | 1 | **1.2.1.6.1.1 BPM's** |  |  | 2006-10-02 | 2013-08-30 |  |  |  |  |  |  |  |  |  |  |  |  |  |  |  |  |  |  |  |  |  |  |
| 121611007LOE |  | FY07 Management Effort (BPMs) |  | 247d | 2006-10-02 | 2007-09-28 | 9-070M | 111d | 0d | SR STAFF [69.6 h] | 6,933.1 | 2007-09-28 | GARZA O | 1 | 1 | 1.2.1.6.1.1 | MIKE S |  |  |  |  |  |  |  |  | 09-012 |  |  |
| 121611010 |  | Define & Package System Layout (BPMs) |  | 22.5d | 2006-12-05 | 2007-01-12 | 9-070M FS+44d | 268d | 0d | SCIENTIST [52.4 h]; ELEC ENG [52.2 h] | 6,812.41 | 2007-01-12 | GARZA O | 1 | 1 | 1.2.1.6.1.1 | MIKE S |  |  |  |  |  |  |  |  |  |  |  |
| 121611015 |  | Design Top-Level System Layout (BPMs) |  | 22.5d | 2007-01-12 | 2007-02-14 | 121611010 | 268d | 0d | ELEC ENG [87 h]; ELEC DES [121.8 h]; SCIENTIST [34.8 h]; ELEC TECH [87 h] | 17,064 | 2007-02-14 | GARZA O | 1 | 1 | 1.2.1.6.1.1 | MIKE S |  |  |  |  |  |  |  |  |  |  |  |
| 121611020 |  | Evaluate System Interface (BPMs) |  | 22.5d | 2007-01-12 | 2007-02-14 | 121611010 | 268d | 0d | COMP SCIENT [34.8 h] | 2,015.62 | 2007-02-14 | GARZA O | 1 | 1 | 1.2.1.6.1.1 | MIKE S |  |  |  |  |  |  |  |  |  |  |  |
| 121611030M |  | Ready to Baseline (BPMs) | milestone | 0d | 2007-02-14 | 2007-02-14 | 121611020 | 268d | 0d |  |  | 2007-02-14 | GARZA O | 1 | 1 | 1.2.1.6.1.1 | MIKE S |  |  |  |  |  | 6 |  |  |  |  |  |
| 121611025 |  | Preliminary Design & Safety Review (BPMs) |  | 1d | 2007-02-15 | 2007-02-15 | 121611030M, 121611015, 121611020 | 268d | 0d | ELEC ENG [6.96 h] | 459.85 | 2007-02-15 | GARZA O | 1 | 1 | 1.2.1.6.1.1 | MIKE S |  |  |  |  |  |  |  |  |  |  |  |
| 121611025M |  | Complete Preliminary Design & Safety Review (BPMs) | milestone | 0d | 2007-02-15 | 2007-02-15 | 121611025 | 268d | 157d |  |  | 2007-02-15 | GARZA O | 1 | 1 | 1.2.1.6.1.1 | MIKE S |  |  |  |  |  | 5 |  |  |  |  |  |
| 121611040 |  | FY08 Comp BPM Sys Dsgn |  | 90d | 2007-10-01 | 2008-02-15 | 121611007LOE, 121611025M, 9-080M | 111d | 0d | ELEC ENG [180 h]; ELEC TECH [120 h]; COMP SCIENT [80 h]; SCIENTIST [80 h] | 25,486 |  | GARZA O | 1 | 1 | 1.2.1.6.1.1 | MIKE S | 07-027 |  |  |  |  |  |  |  |  |  |  |
| 121611908LOE |  | FY08 Mngmnt Effort for BPMs |  | 248d | 2007-10-01 | 2008-09-30 | 9-080M | 20d | 0d | SR STAFF [80 h] | 7,972.8 |  | GARZA O | 1 | 1 | 1.2.1.6.1.1 | MIKE S |  |  |  |  |  |  |  |  |  |  |  |
| 121611041 |  | Pre-Constrctn Final Dsgn Review for BPM's |  | 5d | 2008-02-19 | 2008-02-25 | 121611040 | 111d | 0d | ELEC ENG [20 h] | 1,244.8 |  | GARZA O | 1 | 1 | 1.2.1.6.1.1 | MIKE S | 07-027 |  |  |  |  |  |  |  |  | C |  |
| 121611045 |  | Compile Mech BPM Prcrmnt Packages |  | 40d | 2008-07-02 | 2008-08-27 | 121611041 FS+90d | 271d | 183d | ELEC ENG [80 h]; ELEC TECH [80 h]; SCIENTIST [40 h]; TRAVEL; PROCUREMENT<$50K 60 | 18,901.51 |  | GARZA O | 1 | 1 | 1.2.1.6.1.1 | MIKE S |  |  |  |  |  |  |  |  |  |  |  |
| 13611909LOEX |  | FY09 Mngmnt Effort for BPMs |  | 59d | 2008-10-01 | 2008-12-24 | 121612908LOE, 121611908LOE | 20d | 0d | SR STAFF [1.9 h] | 195.4 |  | GARZA O | 1 | 1 |  | MIKE S |  |  |  |  |  |  |  |  |  |  | 08-058 |
| 121611050 |  | Compile Elect BPM Prcrmnt Packages |  | 40d | 2009-04-01 | 2009-05-27 | 9-090M FS+120d, 121611041 | 88d | 0d | TRAVEL; PROCUREMENT<$50K 60; ELEC ENG [120 h]; ELEC TECH [80 h]; SCIENTIST [40 h] | 22,191.16 |  | GARZA O | 1 | 1 | 1.2.1.6.1.1 | MIKE S | 07-027 |  |  |  |  |  |  |  |  |  |  |
| 121611055M |  | BPM PED Comp++ | milestone | 0d | 2009-05-27 | 2009-05-27 | 121611045, 121611050 | 88d |  |  |  |  | GARZA O | 1 | 1 | 1.2.1.6.1.1 | MIKE S | 07-027 |  |  |  |  | 6 |  |  |  |  |  |
| 121611060 |  | Re-Baseline Actuals Adjustment |  | 1d | 2013-08-30 | 2013-08-30 | 9-130M FS+227d | 20d |  | PROCUREMENT>$50K 69 NO ESCALATION | -47,841.98 |  | GARZA O | 1 | 1 |  | MIKE S |  |  |  |  |  |  | 13-014 | ADJ |  |  |  |

| ID | WBS | Activity | Type | Duration | Start | Finish | Predecessors | Total float | Free float | Resources | Cost | Planned FinishUDF | RESP - Responsibility | STRT%COMP for CM EVM | FNSH%COMP for CM EVM | WBS ASSIGNMENT | CAM RESPONSIBLE | CR 09-012 | Milestone Level | Profile change | CR 08-058 | CR 07-027 | CR 13-014 | ReBaseline Actuals Adjustment |
| --- | --- | --- | --- | --- | --- | --- | --- | --- | --- | --- | --- | --- | --- | --- | --- | --- | --- | --- | --- | --- | --- | --- | --- | --- |
|  | 2 | **1.2.1.6.1.2 HARPS** |  |  | 2006-10-02 | 2013-08-30 |  |  |  |  |  |  |  |  |  |  |  |  |  |  |  |  |  |  |
| 121612007LOE |  | FY07 Management Effort Harps (HARPS) |  | 247d | 2006-10-02 | 2007-09-28 | 9-070M | 20d | 0d | SR STAFF [34.8 h] | 3,466.55 | 2007-09-28 | GARZA O | 1 | 1 | 1.2.1.6.1.2 | MIKE S | 09-012 |  |  |  |  |  |  |
| 121612010 |  | Design Top-Level System Layout (HARPS) |  | 22.5d | 2006-10-02 | 2006-11-01 | 9-070M | 327d | 0d | ELEC ENG [34.8 h]; ELEC DES [34.8 h] | 3,864.54 | 2006-11-01 | GARZA O | 1 | 1 | 1.2.1.6.1.2 | MIKE S |  |  |  |  |  |  |  |
| 121612011 |  | Preliminary Design & Safety Review Harps (HARPS) |  | 1d | 2007-02-28 | 2007-03-01 | 121612010 FS+75d | 327d | 0d | ELEC ENG [6.96 h] | 459.85 | 2007-03-01 | GARZA O | 1 | 1 | 1.2.1.6.1.2 | MIKE S |  |  |  |  |  |  |  |
| 121612015M |  | Complete Preliminary Design & Safety Review Harps (HARPS) | milestone | 0d | 2007-03-01 | 2007-03-01 | 121612011 | 327d | 148.5d |  |  | 2007-03-01 | GARZA O | 1 | 1 | 1.2.1.6.1.2 | MIKE S |  | 5 |  |  |  |  |  |
| 121612020M |  | Ready to baseline Harp WBS (HARPS) | milestone | 0d | 2007-03-01 | 2007-03-01 | 121612010 FS+76d | 327d | 148.5d |  |  | 2007-03-01 | GARZA O | 1 | 1 | 1.2.1.6.1.2 | MIKE S |  | 6 |  |  |  |  |  |
| 121612021 |  | FY08 Comp Harp Sys Dsgn |  | 25d | 2007-10-01 | 2007-11-02 | 121612015M, 9-080M, 121612020M | 178.5d | 0d |  |  |  | GARZA O | 1 | 1 | 1.2.1.6.1.2 | MIKE S |  |  |  |  |  |  |  |
| 121612908LOE |  | FY08 Mngmnt Effort Harps |  | 248d | 2007-10-01 | 2008-09-30 | 121612007LOE | 20d | 0d | SR STAFF [40 h] | 3,986.4 |  | GARZA O | 1 | 1 | 1.2.1.6.1.2 | MIKE S |  |  |  |  |  |  |  |
| 121612022 |  | Pre-Constrctn Final Dsgn Review for Harps |  | 2.5d | 2007-11-05 | 2007-11-07 | 121612021 | 178.5d |  |  |  |  | GARZA O | 1 | 1 | 1.2.1.6.1.2 | MIKE S |  |  | C |  |  |  |  |
| 13612909LOEX |  | FY09 Mngmnt Effort for Harps |  | 59d | 2008-10-01 | 2008-12-24 | 121612908LOE | 20d | 0d | SR STAFF [7.61 h] | 782.61 |  | GARZA O | 1 | 1 |  | MIKE S |  |  |  | 08-058 |  |  |  |
| 121612030 |  | Compile Harp Sys Elect Prcrmnt Packages+ |  | 21.5d | 2009-04-08 | 2009-05-07 | 121612022, 9-090M FS+125d | 101.5d |  | ELEC TECH [20 h]; SCIENTIST [40 h]; ELEC ENG [20 h] | 4,658.4 |  | GARZA O | 1 | 1 | 1.2.1.6.1.2 | MIKE S |  |  |  |  | 07-027 |  |  |
| 121612035 |  | Compile Harp Sys Mech Prcrmnt Packages+ |  | 21.5d | 2009-04-08 | 2009-05-07 | 121612022, 9-090M FS+125d | 101.5d |  | ELEC TECH [20 h]; ELEC ENG [20 h] | 2,088 |  | GARZA O | 1 | 1 | 1.2.1.6.1.2 | MIKE S |  |  |  |  | 07-027 |  |  |
| 121612040 |  | Re-Baseline Actuals Adjustment |  | 1d | 2013-08-30 | 2013-08-30 | 9-130M FS+227d | 20d |  | PROCUREMENT>$50K 69 NO ESCALATION | 3,744.22 |  | GARZA O | 1 | 1 |  | MIKE S |  |  |  |  |  | 13-014 | ADJ |
|  | 3 | **1.2.1.6.1.3 VIEWERS** |  |  | 2006-10-02 | 2013-08-30 |  |  |  |  |  |  |  |  |  |  |  |  |  |  |  |  |  |  |
| 121613007LOE |  | FY07 Management Effort for Viewers (VIEWERS) |  | 247d | 2006-10-02 | 2007-09-28 | 9-070M | 20d | 0d | SR STAFF [34.8 h] | 3,466.55 | 2007-09-28 | GARZA O | 1 | 1 | 1.2.1.6.1.3 | MIKE S | 09-012 |  |  |  |  |  |  |
| 121613010 |  | Design Top-Level System Layout (VIEWERS) |  | 22.5d | 2006-10-02 | 2006-11-01 | 9-070M | 327d | 0d | ELEC ENG [34.8 h]; ELEC DES [34.8 h] | 3,864.54 | 2006-11-01 | GARZA O | 1 | 1 | 1.2.1.6.1.3 | MIKE S |  |  |  |  |  |  |  |
| 121613011 |  | Preliminary Design & Safety Review Viewers (VIEWERS) |  | 1d | 2007-02-28 | 2007-03-01 | 121613010 FS+75d | 327d | 0d | ELEC ENG [6.96 h] | 459.85 | 2007-03-01 | GARZA O | 1 | 1 | 1.2.1.6.1.3 | MIKE S |  |  |  |  |  |  |  |
| 121613015M |  | Complete Preliminary Design & Safety Review Viewers (VIEWERS) | milestone | 0d | 2007-03-01 | 2007-03-01 | 121613011 | 327d | 0.5d |  |  | 2007-03-01 | GARZA O | 1 | 1 | 1.2.1.6.1.3 | MIKE S |  | 5 |  |  |  |  |  |
| 121613020M |  | Ready to Baseline Viewers (VIEWERS) | milestone | 0d | 2007-03-01 | 2007-03-01 | 121613015M, 121613010 FS+76d, 121614015M | 326.5d | 148d |  |  | 2007-03-01 | GARZA O | 1 | 1 | 1.2.1.6.1.3 | MIKE S |  | 6 |  |  |  |  |  |
| 121613026 |  | FY08 Comp Viewer Sys Dsgn |  | 25d | 2007-10-01 | 2007-11-02 | 121613020M, 9-080M | 178.5d | 0d |  |  |  | GARZA O | 1 | 1 | 1.2.1.6.1.3 | MIKE S |  |  |  |  |  |  |  |
| 121613908LOE |  | FY08 Mngmnt Effort for Viewers |  | 248d | 2007-10-01 | 2008-09-30 | 121613007LOE, 9-080M | 20d | 0d | SR STAFF [40 h] | 3,986.4 |  | GARZA O | 1 | 1 | 1.2.1.6.1.3 | MIKE S |  |  |  |  |  |  |  |
| 121613027 |  | Pre-Constrctn Final Dsgn Review for Viewers |  | 2.5d | 2007-11-05 | 2007-11-07 | 121613026 | 178.5d |  |  |  |  | GARZA O | 1 | 1 | 1.2.1.6.1.3 | MIKE S |  |  | C |  |  |  |  |
| 13613909LOEX |  | FY09 Mngmnt Effort for Viewer Syss |  | 59d | 2008-10-01 | 2008-12-24 | 121613908LOE | 20d | 0d | SR STAFF [7.61 h] | 782.61 |  | GARZA O | 1 | 1 |  | MIKE S |  |  |  | 08-058 |  |  |  |
| 121613030 |  | Compile Viewer Sys Elect Prcrmnt Packages |  | 50d | 2009-04-01 | 2009-06-10 | 121613027, 9-090M FS+120d | 78d | 5d | SCIENTIST [40 h]; ELEC ENG [20 h]; ELEC TECH [20 h] | 4,658.4 |  | GARZA O | 1 | 1 | 1.2.1.6.1.3 | MIKE S |  |  |  |  | 07-027 |  |  |
| 121613035 |  | Compile Viewer Sys Mech Prcrmnt Packages |  | 55d | 2009-04-01 | 2009-06-17 | 121613027, 9-090M FS+120d | 73d | 0d | ELEC ENG [20 h]; ELEC TECH [20 h]; SUPPLIES & MATERIALS | 3,184.76 |  | GARZA O | 1 | 1 | 1.2.1.6.1.3 | MIKE S |  |  |  |  | 07-027 |  |  |
| 121613040M |  | Viewer Sys PED Comp++ | milestone | 0d | 2009-06-17 | 2009-06-17 | 121613035, 121613030 | 73d |  |  |  |  | GARZA O | 1 | 1 | 1.2.1.6.1.3 | MIKE S |  | 6 |  |  | 07-027 |  |  |
| 121613045 |  | Re-Baseline Actuals Adjustment |  | 1d | 2013-08-30 | 2013-08-30 | 9-130M FS+227d | 20d |  | PROCUREMENT>$50K 69 NO ESCALATION | 8,544.56 |  | GARZA O | 1 | 1 |  | MIKE S |  |  |  |  |  | 13-014 | ADJ |

| ID | WBS | Activity | Type | Duration | Start | Finish | Predecessors | Total float | Free float | Resources | Cost | Planned FinishUDF | RESP - Responsibility | STRT%COMP for CM EVM | FNSH%COMP for CM EVM | CR 07-027 | WBS ASSIGNMENT | CAM RESPONSIBLE | CR 09-012 | Milestone Level | Profile change | CR 08-058 | CR 13-014 | ReBaseline Actuals Adjustment |
| --- | --- | --- | --- | --- | --- | --- | --- | --- | --- | --- | --- | --- | --- | --- | --- | --- | --- | --- | --- | --- | --- | --- | --- | --- |
|  | 4 | **1.2.1.6.1.4 BEAM-BASED FEEDBACK SYSTEMS** |  |  | 2006-10-02 | 2013-08-30 |  |  |  |  |  |  |  |  |  |  |  |  |  |  |  |  |  |  |
| 121614007LOE |  | FY07 Management Effort for Beam Based Feedback (BEAM-BASED FB SYS) |  | 247d | 2006-10-02 | 2007-09-28 | 9-070M | 20d | 0d | SR STAFF [34.8 h] | 3,466.55 | 2007-09-28 | GARZA O | 1 | 1 | 07-027 | 1.2.1.6.1.4 | MIKE S | 09-012 |  |  |  |  |  |
| 121614010 |  | Define System Requirements & High Level Design (BEAM-BASED FB SYS) |  | 40d | 2006-10-02 | 2006-11-28 | 9-070M | 324d | 0d | SCIENTIST [45.24 h]; COMP SCIENT [46.98 h]; ELEC ENG [46.98 h] | 8,729.01 | 2006-11-28 | GARZA O | 1 | 1 |  | 1.2.1.6.1.4 | MIKE S |  |  |  |  |  |  |
| 121614011 |  | Preliminary Design & Safety Review Beam Based Feedback Systems (BEAM-BASED FB SYS) |  | 1d | 2007-03-01 | 2007-03-01 | 121614010 FS+58d | 326.5d | 0d | ELEC ENG [6.96 h] | 459.85 | 2007-03-01 | GARZA O | 1 | 1 |  | 1.2.1.6.1.4 | MIKE S |  |  |  |  |  |  |
| 121614015M |  | Complete Preliminary Design & Safety Review BBFB (BEAM-BASED FB SYS) | milestone | 0d | 2007-03-01 | 2007-03-01 | 121614011 | 326.5d | 0d |  |  | 2007-03-01 | GARZA O | 1 | 1 |  | 1.2.1.6.1.4 | MIKE S |  | 5 |  |  |  |  |
| 121614020M |  | Ready to Baseline Beam Based Feedback System (BEAM-BASED FB SYS) | milestone | 0d | 2007-03-01 | 2007-03-01 | 121614010 FS+59d | 324d | 148d |  |  | 2007-03-01 | GARZA O | 1 | 1 |  | 1.2.1.6.1.4 | MIKE S |  | 6 |  |  |  |  |
| 121614026 |  | FY08 Comp BBFB Sys Dsgn |  | 25d | 2007-10-01 | 2007-11-02 | 121614020M, 9-080M | 176d | 0d |  |  |  | GARZA O | 1 | 1 |  | 1.2.1.6.1.4 | MIKE S |  |  |  |  |  |  |
| 121614908LOE |  | FY08 Mngmnt Effort for Beam Based Feedback 2 |  | 248d | 2007-10-01 | 2008-09-30 | 121614007LOE | 20d | 0d | SR STAFF [40 h] | 3,986.4 |  | GARZA O | 1 | 1 |  | 1.2.1.6.1.4 | MIKE S |  |  |  |  |  |  |
| 121614027 |  | Pre-Constrctn Final Dsgn Review for BBFB |  | 5d | 2007-11-05 | 2007-11-09 | 121614026 | 176d |  |  |  |  | GARZA O | 1 | 1 |  | 1.2.1.6.1.4 | MIKE S |  |  | C |  |  |  |
| 13614909LOEX |  | FY09 FFB Sys Mangement Effort |  | 59d | 2008-10-01 | 2008-12-24 | 121614908LOE | 20d | 0d | SR STAFF [0.95 h] | 97.7 |  | GARZA O | 1 | 1 |  |  | MIKE S |  |  |  | 08-058 |  |  |
| 121614030 |  | Compile BBFB Hardware Prcrmnt Package (Beam-BASED FB SYS) |  | 40d | 2009-04-01 | 2009-05-27 | 9-090M FS+120d, 121614027 | 88d | 0d | SUPPLIES & MATERIALS; ELEC ENG [120 h]; SCIENTIST [160 h]; COMP SCIENT [80 h]; ELEC TECH [120 h] | 30,887.33 |  | GARZA O | 1 | 1 | 07-027 | 1.2.1.6.1.4 | MIKE S |  |  |  |  |  |  |
| 121614035M |  | Beam Based Feedback PED Comp+ | milestone | 0d | 2009-05-27 | 2009-05-27 | 121614030 | 88d |  |  |  |  | GARZA O | 1 | 1 | 07-027 | 1.2.1.6.1.4 | MIKE S |  | 6 |  |  |  |  |
| 121614040 |  | Re-Baseline Actuals Adjustment |  | 1d | 2013-08-30 | 2013-08-30 | 9-130M FS+227d | 20d |  | PROCUREMENT>$50K 69 NO ESCALATION | -40,115.07 |  | GARZA O | 1 | 1 |  |  | MIKE S |  |  |  |  | 13-014 | ADJ |
|  | 2 | **1.2.1.6.2 CONTROL SYSTEM HARDWARE** |  |  | 2006-10-02 | 2013-08-30 |  |  |  |  |  |  |  |  |  |  |  |  |  |  |  |  |  |  |
| 12162007LOE |  | FY07 Management Effort for Control System HW (CONT SYS HW) |  | 247d | 2006-10-02 | 2007-09-28 | 9-070M | 20d | 0d | SR STAFF [36 h] | 3,586.09 | 2007-09-28 | GARZA O | 1 | 1 |  | 1.2.1.6.2 | MIKE S | 09-012 |  |  |  |  |  |
| 12162010 |  | Define & Package System Layout (CONT SYS HW) |  | 22.5d | 2006-12-05 | 2007-01-12 | 9-070M FS+44d | 322d | 0d | ELEC TECH [34.8 h]; ELEC ENG [34.8 h] | 3,740.66 | 2007-01-12 | GARZA O | 1 | 1 |  | 1.2.1.6.2 | MIKE S |  |  |  |  |  |  |
| 12162015 |  | Design Top-Level System Layout (CONT SYS HW) |  | 22.5d | 2007-01-12 | 2007-02-14 | 12162010 | 322d | 0d | ELEC TECH [23.32 h]; ELEC DES [57.77 h]; ELEC ENG [23.32 h] | 5,104.64 | 2007-02-14 | GARZA O | 1 | 1 |  | 1.2.1.6.2 | MIKE S |  |  |  |  |  |  |
| 12162016 |  | Preliminary Design & Safety Review Control System Hardware (CONT SYS HW) |  | 1d | 2007-03-05 | 2007-03-05 | 12162015 FS+11d | 322d | 0d | COMP SCIENT [6.96 h] | 403.12 | 2007-03-05 | GARZA O | 1 | 1 |  | 1.2.1.6.2 | MIKE S |  |  |  |  |  |  |
| 12162020M |  | Complete Preliminary Design & Safety Review Control System HW (CONT SYS HW) | milestone | 0d | 2007-03-05 | 2007-03-05 | 12162016 | 322d | 0d |  |  | 2007-03-05 | GARZA O | 1 | 1 |  | 1.2.1.6.2 | MIKE S |  | 5 |  |  |  |  |
| 12162025M |  | Ready to Baseline Control System Hardware (CONT SYS HW) | milestone | 0d | 2007-03-05 | 2007-03-05 | 12162015 FS+12d, 12163020M, 12162020M | 322d | 146d |  |  | 2007-03-05 | GARZA O | 1 | 1 |  | 1.2.1.6.2 | MIKE S |  | 6 |  |  |  |  |
| 12162026 |  | FY08 Comp CSH Sys Dsgn |  | 25d | 2007-10-01 | 2007-11-02 | 12162025M, 9-080M | 176d | 0d |  |  |  | GARZA O | 1 | 1 |  | 1.2.1.6.2 | MIKE S |  |  |  |  |  |  |
| 12162908LOE |  | FY08 Mngmnt Effort for Control Sys HW 2 |  | 248d | 2007-10-01 | 2008-09-30 | 12162007LOE | 20d | 0d | SR STAFF [80 h] | 7,972.8 |  | GARZA O | 1 | 1 |  | 1.2.1.6.2 | MIKE S |  |  |  |  |  |  |
| 12162027 |  | Pre-Constrctn Final Dsgn Review for CSH |  | 5d | 2007-11-05 | 2007-11-09 | 12162026 | 176d |  |  |  |  | GARZA O | 1 | 1 |  | 1.2.1.6.2 | MIKE S |  |  | C |  |  |  |
| 12162035 |  | Compile CSH Prcrmnt Packages |  | 40d | 2008-10-01 | 2008-11-25 | 9-090M, 12162027 | 208d | 0d | SUPPLIES & MATERIALS; ELEC ENG [160 h] | 11,373.56 |  | GARZA O | 1 | 1 | 07-027 | 1.2.1.6.2 | MIKE S |  |  |  |  |  |  |
| 1362909LOEX |  | FY09 CSH Sys Mngmnt Effort |  | 59d | 2008-10-01 | 2008-12-24 | 12162908LOE | 20d | 0d | SR STAFF [0.95 h] | 97.7 |  | GARZA O | 1 | 1 |  |  | MIKE S |  |  |  | 08-058 |  |  |
| 12162040M |  | PED for Control Sys Hardware Comp+ | milestone | 0d | 2008-11-25 | 2008-11-25 | 12162035 | 208d |  |  |  |  | GARZA O | 1 | 1 | 07-027 | 1.2.1.6.2 | MIKE S |  | 6 |  |  |  |  |
| 12162045 |  | Re-Baseline Actuals Adjustment |  | 1d | 2013-08-30 | 2013-08-30 | 9-130M FS+227d | 20d |  | PROCUREMENT>$50K 69 NO ESCALATION | 5,406.2 |  | GARZA O | 1 | 1 |  |  | MIKE S |  |  |  |  | 13-014 | ADJ |

| ID | WBS | Activity | Type | Duration | Start | Finish | Predecessors | Total float | Free float | Resources | Cost | Planned FinishUDF | RESP - Responsibility | STRT%COMP for CM EVM | FNSH%COMP for CM EVM | WBS ASSIGNMENT | CAM RESPONSIBLE | CR 09-012 | Milestone Level | CR 07-027 | Profile change | CR 08-058 | CR 13-014 | ReBaseline Actuals Adjustment | CR 07-026 | CR 12-037 | CR 08-031 | EXPNS ACT BRIDGING FY SPLIT | CR 08-016 |
| --- | --- | --- | --- | --- | --- | --- | --- | --- | --- | --- | --- | --- | --- | --- | --- | --- | --- | --- | --- | --- | --- | --- | --- | --- | --- | --- | --- | --- | --- |
|  | 3 | **1.2.1.6.3 CONTROL SYSTEM SOFTWARE** |  |  | 2006-10-02 | 2013-08-30 |  |  |  |  |  |  |  |  |  |  |  |  |  |  |  |  |  |  |  |  |  |  |  |
| 12163007LOE |  | FY07Management Effort for Control System Software (CONT SYS SW) |  | 247d | 2006-10-02 | 2007-09-28 | 9-070M | 20d | 0d | SR STAFF [34.8 h] | 3,466.55 | 2007-09-28 | BICKLEY M | 1 | 1 | 1.2.1.6.3 | MIKE S | 09-012 |  |  |  |  |  |  |  |  |  |  |  |
| 12163010 |  | Identify and document hall dependecies (CONT SYS SW) |  | 40d | 2006-10-02 | 2006-11-28 | 9-070M | 343d | 0d | COMP SCIENT [52.2 h] | 3,023.42 | 2006-11-28 | BICKLEY M | 1 | 1 | 1.2.1.6.3 | MIKE S |  |  |  |  |  |  |  |  |  |  |  |  |
| 12163015 |  | Identify and document HLA modifications (CONT SYS SW) |  | 40d | 2006-10-02 | 2006-11-28 | 9-070M | 183d | 0d | COMP SCIENT [52.2 h] | 3,023.42 | 2006-11-28 | BICKLEY M | 1 | 1 | 1.2.1.6.3 | MIKE S |  |  |  |  |  |  |  |  |  |  |  |  |
| 12163020 |  | Preliminary Design & Safety Review Control System Software (CONT SYS SW) |  | 1d | 2007-02-01 | 2007-02-01 | 12163015 FS+39d, 12163010 FS+39d | 343d | 0d | COMP SCIENT [6.96 h] | 403.12 | 2007-02-01 | BICKLEY M | 1 | 1 | 1.2.1.6.3 | MIKE S |  |  |  |  |  |  |  |  |  |  |  |  |
| 12163020M |  | Complete Preliminary Design & Safety Review Control System SW (CONT SYS SW) | milestone | 0d | 2007-02-01 | 2007-02-01 | 12163020 | 343d | 21d |  |  | 2007-02-01 | BICKLEY M | 1 | 1 | 1.2.1.6.3 | MIKE S |  | 5 |  |  |  |  |  |  |  |  |  |  |
| 12163025M |  | Ready to Baseline Control System Software (CONT SYS SW) | milestone | 0d | 2007-02-01 | 2007-02-01 | 12163015 FS+40d | 183d | 167d |  |  | 2007-02-01 | BICKLEY M | 1 | 1 | 1.2.1.6.3 | MIKE S |  | 6 |  |  |  |  |  |  |  |  |  |  |
| 12163035 |  | FY08 Finalize Application Rquirmnts |  | 140d | 2007-10-01 | 2008-04-28 | 12163025M, 9-080M | 16d | 0d | COMP SCIENT [280 h] | 16,203.6 |  | BICKLEY M | 1 | 1 | 1.2.1.6.3 | MIKE S |  |  |  |  |  |  |  |  |  |  |  |  |
| 12163908LOE |  | FY08 Mngmnt Effort for Control Sys Software 2 |  | 248d | 2007-10-01 | 2008-09-30 | 9-080M, 12163007LOE | 20d | 0d | SR STAFF [80 h] | 7,972.8 |  | BICKLEY M | 1 | 1 | 1.2.1.6.3 | MIKE S |  |  |  |  |  |  |  |  |  |  |  |  |
| 12163040 |  | Comp Detailed Application Dsgn (CONT SYS SW) |  | 130d | 2008-01-18 | 2008-07-23 | 12163035 FS-70d | 16d | 0d | COMP SCIENT [280 h] | 16,203.6 |  | BICKLEY M | 1 | 1 | 1.2.1.6.3 | MIKE S |  |  | 07-027 |  |  |  |  |  |  |  |  |  |
| 12163170 |  | Pre-Constrctn Dsgn Review |  | 5d | 2008-06-18 | 2008-06-24 | 12163040 FS-25d | 26d |  |  |  |  | BICKLEY M | 1 | 1 | 1.2.1.6.3 | MIKE S |  |  |  | C |  |  |  |  |  |  |  |  |
| 1363909LOEX |  | FY09 CSS Sys Mngmnt Effort |  | 59d | 2008-10-01 | 2008-12-24 | 12163908LOE | 20d | 0d | SR STAFF [5.71 h] | 587.22 |  | BICKLEY M | 1 | 1 |  | MIKE S |  |  |  |  | 08-058 |  |  |  |  |  |  |  |
| 12163045 |  | Comp Implementn Plan (CONT SYS SW) |  | 110d | 2009-04-03 | 2009-09-08 | 12163040 FS+170d | 16d | 0d | COMP SCIENT [320 h]; SUPPLIES & MATERIALS | 22,514.62 |  | BICKLEY M | 1 | 1 | 1.2.1.6.3 | MIKE S |  |  | 07-027 |  |  |  |  |  |  |  |  |  |
| 12163050M |  | Control Sys Software PED Comp+ | milestone | 0d | 2009-09-08 | 2009-09-08 | 12163045 | 16d |  |  |  |  | BICKLEY M | 1 | 1 | 1.2.1.6.3 | MIKE S |  | 6 | 07-027 |  |  |  |  |  |  |  |  |  |
| 12163175 |  | Re-Baseline Actuals Adjustment |  | 1d | 2013-08-30 | 2013-08-30 | 9-130M FS+227d | 20d |  | PROCUREMENT>$50K 69 NO ESCALATION | -36,894.1 |  | BICKLEY M | 1 | 1 |  | MIKE S |  |  |  |  |  | 13-014 | ADJ |  |  |  |  |  |
|  | 4 | **1.2.1.6.4 SAFETY SYSTEMS** |  |  | 2006-10-02 | 2013-08-30 |  |  |  |  |  |  |  |  |  |  |  |  |  |  |  |  |  |  |  |  |  |  |  |
|  | 1 | **1.2.1.6.4.1 MACHINE PROTECTION** |  |  | 2006-10-02 | 2013-08-30 |  |  |  |  |  |  |  |  |  |  |  |  |  |  |  |  |  |  |  |  |  |  |  |
| 121641007LOE |  | FY07 Management effort for Machine Protection Systems (MACHINE PROTECT) |  | 247d | 2006-10-02 | 2007-09-28 | 9-070M | 20d | 0d | SR STAFF [34.8 h] | 3,466.55 | 2007-09-28 | MAHONEY K | 1 | 1 | 1.2.1.6.4.1 | MIKE S | 09-012 |  |  |  |  |  |  |  |  |  |  |  |
| 121641010 |  | Define MPS System Requirements (MACHINE PROTECT) |  | 162d | 2006-11-01 | 2007-06-29 | 9-070M FS+22d | 734d | 0d | ELEC ENG [27.84 h] | 1,795.94 | 2006-12-22 | MAHONEY K | 1 | 1 | 1.2.1.6.4.1 | MIKE S |  |  |  |  |  |  |  | 07-026 | 12-037F |  |  |  |
| 121641025 |  | Design and Test Eng Dev Ion Chamber (MACHINE PROTECT) |  | 131d | 2006-12-18 | 2007-06-29 | 9-070M FS+53d | 726.5d | 0d | ELEC DES [5.2 h]; SUPPLIES & MATERIALS; SCIENTIST [5.2 h]; ELEC TECH [26.08 h]; ELEC ENG [26.08 h] | 3,704.2 | 2007-04-13 | MAHONEY K | 1 | 1 | 1.2.1.6.4.1 | MIKE S |  |  |  |  |  |  |  | 07-026 | 12-037F |  |  |  |
| 121641015 |  | Design System Detail Architecture (MACHINE PROTECT) |  | 98d | 2007-02-12 | 2007-06-29 | 9-070M FS+86d | 800.5d | 0d | ELEC ENG [22.62 h] | 1,436.15 | 2007-04-04 | MAHONEY K | 1 | 1 | 1.2.1.6.4.1 | MIKE S |  |  |  |  |  |  |  | 07-026 | 12-037F |  |  |  |
| 121641020 |  | Design FSD Master (MACHINE PROTECT) |  | 74d | 2007-03-19 | 2007-06-29 | 9-070M FS+110d | 711.5d | 0d | ELEC DES [15.34 h]; ELEC TECH [37.44 h]; ELEC ENG [15.08 h]; SUPPLIES & MATERIALS | 3,450.71 | 2007-05-31 | MAHONEY K | 1 | 1 | 1.2.1.6.4.1 | MIKE S |  |  |  |  |  |  |  | 07-026 | 12-037F |  |  |  |
| 121641010A |  | Define MPS System Requirements (MACHINE PROTECT) |  | 28.5d | 2007-10-01 | 2007-11-08 | 121641010 FS+63d | 734d | 22.5d | ELEC ENG [6.96 h] | 433.19 | 2006-12-22 | MAHONEY K | 1 | 1 | 1.2.1.6.4.1 | MIKE S |  |  |  |  |  |  |  | 07-026 | 12-037F |  |  |  |
| 121641015A |  | Design System Detail Architecture (MACHINE PROTECT) |  | 3d | 2007-10-01 | 2007-10-03 | 121641015 FS+63d | 800.5d | 89d | ELEC ENG [12.18 h] | 758.08 | 2007-04-04 | MAHONEY K | 1 | 1 | 1.2.1.6.4.1 | MIKE S |  |  |  |  |  |  |  | 07-026 | 12-037F |  |  |  |
| 121641020A |  | Design FSD Master (MACHINE PROTECT) |  | 72d | 2007-10-01 | 2008-01-22 | 121641020 FS+63d | 711.5d | 0d | ELEC ENG [8.12 h]; SUPPLIES & MATERIALS; ELEC DES [8.26 h]; ELEC TECH [20.16 h] | 1,844.56 | 2007-05-31 | MAHONEY K | 1 | 1 | 1.2.1.6.4.1 | MIKE S |  |  |  |  |  |  |  | 07-026 | 12-037F |  |  |  |
| 121641025A |  | Design and Test Eng Dev Ion Chamber (MACHINE PROTECT) |  | 56d | 2007-10-01 | 2007-12-19 | 121641025 FS+63d | 726.5d | 15d | ELEC TECH [104.32 h]; ELEC DES [20.8 h]; SUPPLIES & MATERIALS; SCIENTIST [20.8 h]; ELEC ENG [104.32 h] | 14,479.79 | 2007-04-13 | MAHONEY K | 1 | 1 | 1.2.1.6.4.1 | MIKE S |  |  |  |  |  |  |  | 07-026 | 12-037F |  |  |  |
| 121641030 |  | Complete Internal Preliminary Design & Safety Review (MACHINE PROTECT) |  | 5d | 2007-10-24 | 2007-10-30 | 121641015A FS-75d, 121641020A FS-55d, 121641010A FS-34d | 711.5d | 0d | ELEC ENG [17.2 h] | 1,070.53 | 2007-03-21 | MAHONEY K | 1 | 1 | 1.2.1.6.4.1 | MIKE S |  |  |  |  |  |  |  |  | 12-037F |  |  |  |
| 121641035 |  | Complete External Preliminary Design & Safety Review (MACHINE PROTECT) |  | 5d | 2007-11-13 | 2007-11-19 | 121641030 FS+9d, 121641025A FS-40d | 711.5d | 0d | ELEC ENG [17.2 h]; TRAVEL | 2,669.98 | 2007-05-07 | MAHONEY K | 1 | 1 | 1.2.1.6.4.1 | MIKE S |  |  |  |  |  |  |  |  | 12-037F |  |  |  |
| 121641040M |  | MPS 35% Design Complete (MACHINE PROTECT) | milestone | 0d | 2007-12-17 | 2007-12-17 | 121641035 FS+18d | 711.5d | 0d |  |  | 2007-06-01 | MAHONEY K | 1 | 1 | 1.2.1.6.4.1 | MIKE S |  | 5 |  |  |  |  |  |  | 12-037F |  |  |  |
| 121641045M |  | Start P-#2 of MPS PED - FY08 | milestone | 0d | 2007-12-18 | 2007-12-18 | 9-080M, 121641040M | 711.5d | 0d |  |  |  | MAHONEY K | 1 | 1 | 1.2.1.6.4.1 | MIKE S |  | 6 |  |  |  |  |  |  | 12-037F |  |  |  |
| 121641050 |  | Detail Dsgn FSD Sys (MACHINE PROTECT) |  | 45d | 2007-12-18 | 2008-02-29 | 121641045M, 9-080M | 711.5d | 0d | COMP SCIENT [20 h]; ELEC ENG [60 h] | 4,891.8 |  | MAHONEY K | 1 | 1 | 1.2.1.6.4.1 | MIKE S |  |  |  |  |  |  |  |  | 12-037F |  |  |  |
| 121641055 |  | Develop FSD CAD Drawigns to 80% (MACHINE PROTECT) |  | 30d | 2008-03-03 | 2008-04-11 | 121641050 | 711.5d | 0d | ELEC DES [80 h]; ELEC ENG [40 h]; ELEC TECH [40 h] | 7,610.8 |  | MAHONEY K | 1 | 1 | 1.2.1.6.4.1 | MIKE S |  |  |  |  |  |  |  | 07-026 | 12-037F |  |  |  |
| 121641060 |  | FSD Dsgn & Safty Review (MACHINE PROTECT) |  | 10d | 2008-06-30 | 2008-07-14 | 121641055 FS+54d | 806.5d | 95d | ELEC ENG [40 h]; SUPPLIES & MATERIALS | 3,021.03 |  | MAHONEY K | 1 | 1 | 1.2.1.6.4.1 | MIKE S |  |  |  |  |  |  |  |  | 12-037F | 08-031 |  |  |
| 121641065 |  | FSD Mock-up (MACHINE PROTECT) |  | 30d | 2008-06-30 | 2008-08-11 | 121641055 FS+54d | 711.5d | 0d | ELEC TECH [80 h]; ELEC ENG [60 h]; PROCUREMENT<$50K 60 | 11,110.55 |  | MAHONEY K | 1 | 1 | 1.2.1.6.4.1 | MIKE S |  |  |  |  |  |  |  | 07-026 | 12-037F | 08-031 |  |  |
| 121641070 |  | FY08 Detail Dsgn BLM Sys (MACHINE PROTECT) |  | 35d | 2008-08-12 | 2008-09-30 | 121641065 | 711.5d | 0d | COMP SCIENT [62.22 h]; MECH DES [31.11 h]; ELEC ENG [93.33 h]; SCIENTIST [31.11 h] | 12,668.3 |  | MAHONEY K | 1 | 1 | 1.2.1.6.4.1 | MIKE S |  |  |  |  |  |  |  | 07-026 | 12-037F | 08-031 | EXP0809 |  |
| 121641070a |  | FY09 Detail Dsgn BLM Sys (MACHINE PROTECT) |  | 10d | 2008-10-01 | 2008-10-14 | 121641070 | 711.5d | 0d | ELEC ENG [26.67 h]; SCIENTIST [8.89 h]; COMP SCIENT [17.78 h]; MECH DES [8.89 h] | 3,735.66 |  | MAHONEY K | 1 | 1 | 1.2.1.6.4.1 | MIKE S |  |  |  |  |  |  |  | 07-026 | 12-037F | 08-031 | EXP0809 |  |
| 13641909LOEX |  | FY09 Mngmnt & Elect Dsgn Supprt Effort for MPS |  | 59d | 2008-10-01 | 2008-12-24 | 9-090M, 121642908LOE | 20d | 0d | ELEC DES [0.95 h]; SR STAFF [0.95 h] | 141.38 |  | MAHONEY K | 1 | 1 |  | MIKE S |  |  |  |  | 08-058 |  |  |  |  |  |  |  |
| 121641075 |  | Develop BLM CAD Drawigns to 80% (MACHINE PROTECT) |  | 15d | 2008-10-15 | 2008-11-04 | 121641070a | 711.5d | 0d | ELEC TECH [60 h]; ELEC ENG [80 h]; ELEC DES [60 h] | 10,307.4 |  | MAHONEY K | 1 | 1 | 1.2.1.6.4.1 | MIKE S |  |  |  |  |  |  |  | 07-026 | 12-037F | 08-031 |  |  |
| 121641170 |  | Pre-Constrctn Dsgn Review++ |  | 7.5d | 2008-10-17 | 2008-10-28 | 121641110M FS-110d | 814d | 784d |  |  |  | MAHONEY K | 1 | 1 | 1.2.1.6.4.1 | MIKE S |  |  |  | C |  |  |  | 07-026 | 12-037F | 08-031 |  |  |
| 121641080 |  | BLM Dsgn Review (MACHINE PROTECT) |  | 15d | 2008-11-05 | 2008-11-25 | 121641075 | 711.5d | 0d | SUPPLIES & MATERIALS; ELEC ENG [40 h] | 3,117.58 |  | MAHONEY K | 1 | 1 | 1.2.1.6.4.1 | MIKE S |  |  |  |  |  |  |  | 07-026 | 12-037F | 08-031 |  |  |
| 121641085 |  | BLM Mock-up (MACHINE PROTECT) |  | 30d | 2008-11-05 | 2008-12-18 | 121641075 | 779d | 67.5d | PROCUREMENT<$50K 60; ELEC ENG [20 h]; ELEC TECH [80 h] | 9,108.86 |  | MAHONEY K | 1 | 1 | 1.2.1.6.4.1 | MIKE S | 09-012 |  |  |  |  |  |  | 07-026 | 12-037F | 08-031 |  | 08-016 |
| 121641090 |  | Machine Protection Sys Dsgn & Safty Review |  | 15d | 2008-11-26 | 2008-12-18 | 121641060, 121641080 | 711.5d | 0d | ELEC ENG [80 h]; TRAVEL | 7,449.05 |  | MAHONEY K | 1 | 1 | 1.2.1.6.4.1 | MIKE S |  |  |  |  |  |  |  | 07-026 | 12-037F | 08-031 |  |  |
| 121641095 |  | Update MPS Dsgn Based on Desgin Review |  | 22.5d | 2008-12-19 | 2009-01-29 | 121641090 | 711.5d | 0d | ELEC DES [20 h]; ELEC ENG [20 h] | 2,204.2 |  | MAHONEY K | 1 | 1 | 1.2.1.6.4.1 | MIKE S |  |  |  |  |  |  |  | 07-026 | 12-037F | 08-031 |  |  |
| 121641100 |  | Develop FSD Proc Packages (MACHINE PROTECT) |  | 45d | 2009-01-29 | 2009-04-03 | 121641095 | 711.5d | 0d | ELEC TECH [40 h]; ELEC ENG [60 h] | 5,460.6 |  | MAHONEY K | 1 | 1 | 1.2.1.6.4.1 | MIKE S |  |  |  |  |  |  |  | 07-026 | 12-037F | 08-031 |  |  |
| 121641105 |  | Develop BLM Proc Packages (MACHINE PROTECT) |  | 45d | 2009-01-29 | 2009-04-03 | 121641095 | 711.5d | 0d | SR STAFF [40 h]; ELEC ENG [40 h]; ELEC TECH [40 h] | 8,289.6 |  | MAHONEY K | 1 | 1 | 1.2.1.6.4.1 | MIKE S |  |  |  |  |  |  |  | 07-026 | 12-037F | 08-031 |  |  |
| 121641110M |  | MPS PED Comp++ | milestone | 0d | 2009-04-03 | 2009-04-03 | 121641065, 121641100, 121641105, 121641085 | 711.5d | 0d |  |  |  | MAHONEY K | 1 | 1 | 1.2.1.6.4.1 | MIKE S |  | 6 |  |  |  |  |  |  | 12-037F | 08-031 |  |  |
| 121641175 |  | Re-Baseline Actuals Adjustment |  | 1d | 2013-08-30 | 2013-08-30 | 9-130M FS+227d | 20d |  | PROCUREMENT>$50K 69 NO ESCALATION | 43,713.68 |  | MAHONEY K | 1 | 1 |  | MIKE S |  |  |  |  |  | 13-014 | ADJ |  |  |  |  |  |

| ID | WBS | Activity | Type | Duration | Start | Finish | Predecessors | Total float | Free float | Resources | Cost | Planned FinishUDF | RESP - Responsibility | STRT%COMP for CM EVM | FNSH%COMP for CM EVM | WBS ASSIGNMENT | CAM RESPONSIBLE | CR 09-012 | CR 07-026 | Milestone Level | Profile change | CR 08-031 | CR 08-058 | CR 13-014 | ReBaseline Actuals Adjustment | EXPNS ACT BRIDGING FY SPLIT | CR 08-016 |
| --- | --- | --- | --- | --- | --- | --- | --- | --- | --- | --- | --- | --- | --- | --- | --- | --- | --- | --- | --- | --- | --- | --- | --- | --- | --- | --- | --- |
|  | 2 | **1.2.1.6.4.2 BELS** |  |  | 2006-10-02 | 2013-08-30 |  |  |  |  |  |  |  |  |  |  |  |  |  |  |  |  |  |  |  |  |  |
| 121642007LOE |  | FY07 Management Effort for Beam Envelope Limit System (BELS) |  | 247d | 2006-10-02 | 2007-09-28 | 9-070M | 20d | 0d | SR STAFF [34.8 h] | 3,466.55 | 2007-09-28 | MAHONEY K | 1 | 1 | 1.2.1.6.4.2 | MIKE S | 09-012 |  |  |  |  |  |  |  |  |  |
| 121642010 |  | Define BELS System Requirements (BELS) |  | 89d | 2007-02-26 | 2007-06-29 | 9-070M FS+95d | 378d | 0d | ELEC ENG [27.84 h] | 1,760.31 | 2007-03-21 | MAHONEY K | 1 | 1 | 1.2.1.6.4.2 | MIKE S |  | 07-026 |  |  |  |  |  |  |  |  |
| 121642015 |  | Design and Test Eng Dev BELS - Hall D Interface (BELS) |  | 34d | 2007-05-14 | 2007-06-29 | 9-070M FS+150d | 101d | 0d | ELEC TECH [34.8 h]; ELEC ENG [17.4 h]; SUPPLIES & MATERIALS | 3,476.79 | 2007-04-27 | MAHONEY K | 1 | 1 | 1.2.1.6.4.2 | MIKE S |  | 07-026 |  |  |  |  |  |  |  |  |
| 121642020M |  | Complete Preliminary Design & Safety Review (BELS) | milestone | 0d | 2007-07-18 | 2007-07-18 | 121642015 FS+12d | 101d | 0d |  |  | 2007-05-15 | MAHONEY K | 1 | 1 | 1.2.1.6.4.2 | MIKE S |  |  | 5 |  |  |  |  |  |  |  |
| 121642025M |  | 35% Design Complete (BELS) | milestone | 0d | 2007-07-18 | 2007-07-18 | 121642020M | 101d | 51d |  |  | 2007-05-15 | MAHONEY K | 1 | 1 | 1.2.1.6.4.2 | MIKE S |  |  | 5 |  |  |  |  |  |  |  |
| 121642010A |  | Define BELS System Requirements (BELS) |  | 54d | 2007-10-01 | 2007-12-17 | 121642010 FS+63d | 442d |  | ELEC ENG [6.96 h] | 433.19 | 2007-03-21 | MAHONEY K | 1 | 1 | 1.2.1.6.4.2 | MIKE S |  | 07-026 |  |  |  |  |  |  |  |  |
| 121642015A |  | Design and Test Eng Dev BELS - Hall D Interface (BELS) |  | 164d | 2007-10-01 | 2008-06-02 | 121642010 FS+17d, 121642015 FS+63d | 332d |  | SUPPLIES & MATERIALS; ELEC TECH [34.8 h]; ELEC ENG [17.4 h] | 3,500.6 | 2007-04-27 | MAHONEY K | 1 | 1 | 1.2.1.6.4.2 | MIKE S |  | 07-026 |  |  |  |  |  |  |  |  |
| 121642030M |  | Start P-#2 of BELS PED - FY08 | milestone | 0d | 2007-10-01 | 2007-10-01 | 9-080M, 121642025M | 50d | 0d |  |  |  | MAHONEY K | 1 | 1 | 1.2.1.6.4.2 | MIKE S |  |  | 6 |  |  |  |  |  |  |  |
| 121642035 |  | Develop Detail Dsgn (BELS) |  | 100d | 2007-10-01 | 2008-03-03 | 121642030M | 50d | 0d | ELEC ENG [80 h] | 4,979.2 |  | MAHONEY K | 1 | 1 | 1.2.1.6.4.2 | MIKE S |  | 07-026 |  |  |  |  |  |  |  |  |
| 121642908LOE |  | FY08 Mngmnt Effort for BELS |  | 248d | 2007-10-01 | 2008-09-30 | 121642007LOE, 121614007LOE, 121643007LOE, 121641007LOE | 20d | 0d | SR STAFF [40 h] | 3,986.4 |  | MAHONEY K | 1 | 1 | 1.2.1.6.4.2 | MIKE S |  |  |  |  |  |  |  |  |  |  |
| 121642040 |  | Develop mock-up (BELS) |  | 60d | 2008-03-04 | 2008-05-27 | 121642035 | 151d | 101d | ELEC ENG [20 h]; ELEC TECH [40 h]; SUPPLIES & MATERIALS | 3,333.43 |  | MAHONEY K | 1 | 1 | 1.2.1.6.4.2 | MIKE S |  | 07-026 |  |  |  |  |  |  |  |  |
| 121642045 |  | Develop CAD Drawings to 80% BELS |  | 60d | 2008-03-04 | 2008-05-27 | 121642035 | 50d | 0d | ELEC ENG [20 h]; ELEC DES [40 h] | 3,026.8 |  | MAHONEY K | 1 | 1 | 1.2.1.6.4.2 | MIKE S |  | 07-026 |  |  |  |  |  |  |  |  |
| 121642170 |  | Pre-Constrctn Dsgn Review++ |  | 5d | 2008-05-14 | 2008-05-20 | 121642070M FS-110d | 50d |  |  |  |  | MAHONEY K | 1 | 1 | 1.2.1.6.4.2 | MIKE S |  |  |  | C | 08-031 |  |  |  |  |  |
| 121642050 |  | Dsgn Review BELS |  | 10d | 2008-06-26 | 2008-07-10 | 121642045 FS+21d | 50d | 0d | SUPPLIES & MATERIALS; PROCUREMENT<$50K 60 | 2,770.65 |  | MAHONEY K | 1 | 1 | 1.2.1.6.4.2 | MIKE S |  | 07-026 |  |  | 08-031 |  |  |  |  |  |
| 121642055 |  | Update Dsgn Based on Dsgn Review BELS |  | 10d | 2008-07-11 | 2008-07-24 | 121642050 | 50d | 0d |  |  |  | MAHONEY K | 1 | 1 | 1.2.1.6.4.2 | MIKE S |  | 07-026 |  |  | 08-031 |  |  |  |  |  |
| 121642060 |  | Develop Proc Packages BELS |  | 60d | 2008-07-25 | 2008-10-17 | 121642055 | 50d | 0d |  |  |  | MAHONEY K | 1 | 1 | 1.2.1.6.4.2 | MIKE S |  | 07-026 |  |  | 08-031 |  |  |  |  |  |
| 13642909LOEX |  | FY09 Mngmnt & Elect Dsgn Supprt Effort for BELS |  | 59d | 2008-10-01 | 2008-12-24 | 121642908LOE | 20d | 0d | ELEC DES [0.95 h]; SR STAFF [0.95 h] | 141.38 |  | MAHONEY K | 1 | 1 |  | MIKE S |  |  |  |  |  | 08-058 |  |  |  |  |
| 121642070M |  | BELS PED Comp++ | milestone | 0d | 2008-10-17 | 2008-10-17 | 121642040, 121642060 | 50d | 0d |  |  |  | MAHONEY K | 1 | 1 | 1.2.1.6.4.2 | MIKE S |  |  | 6 |  | 08-031 |  |  |  |  |  |
| 121642175 |  | Re-Baseline Actuals Adjustment |  | 1d | 2013-08-30 | 2013-08-30 | 9-130M FS+227d | 20d |  | PROCUREMENT>$50K 69 NO ESCALATION | -2,451.17 |  | MAHONEY K | 1 | 1 |  | MIKE S |  |  |  |  |  |  | 13-014 | ADJ |  |  |
|  | 3 | **1.2.1.6.4.3 PSS** |  |  | 2006-10-02 | 2013-08-30 |  |  |  |  |  |  |  |  |  |  |  |  |  |  |  |  |  |  |  |  |  |
| 121643007LOE |  | FY07 Management effort for Personnel Safety Systems (PSS) |  | 247d | 2006-10-02 | 2007-09-28 | 9-070M | 20d | 0d | SCIENTIST [34.8 h] | 2,193.82 | 2007-09-28 | MAHONEY K | 1 | 1 | 1.2.1.6.4.3 | MIKE S |  |  |  |  |  |  |  |  |  |  |
| 121643010 |  | Define Programmable Electronics Specification (PSS) |  | 184d | 2006-10-02 | 2007-06-29 | 9-070M | 324.75d | 0d | ELEC ENG [93.96 h] | 6,078.84 | 2006-10-13 | MAHONEY K | 1 | 1 | 1.2.1.6.4.3 | MIKE S |  | 07-026 |  |  |  |  |  |  |  |  |
| 121643035 |  | Test Safety PLC 1 & PLC 2 (PSS) |  | 140d | 2006-10-02 | 2007-04-27 | 121643010 FS-220d | 340.75d | 16d | ELEC TECH [226.2 h]; ELEC ENG [121.8 h] | 17,277.68 | 2007-04-27 | MAHONEY K | 1 | 1 | 1.2.1.6.4.3 | MIKE S |  |  |  |  |  |  |  |  |  |  |
| 121643040 |  | Attend Training for Safety PLC Software (PSS) |  | 65d | 2006-10-02 | 2007-01-10 | 9-070M | 363.75d | 39d | ELEC ENG [69.6 h]; TRAVEL | 8,726.47 | 2007-02-12 | MAHONEY K | 1 | 1 | 1.2.1.6.4.3 | MIKE S |  |  |  |  |  |  |  |  |  |  |
| 121643015 |  | Write PSS Systems Safety Specificaiton (PSS) |  | 10d | 2006-11-01 | 2006-11-14 | 9-070M FS+22d | 156.75d | 0d | ELEC ENG [104.4 h] | 6,897.71 | 2006-11-14 | MAHONEY K | 1 | 1 | 1.2.1.6.4.3 | MIKE S |  |  |  |  |  |  |  |  |  |  |
| 121643045 |  | Design Beam Transport Monitor (PSS) |  | 162d | 2006-11-01 | 2007-06-29 | 121643015 FS-10d | 411d | 0d | ELEC DES [28.8 h]; SCIENTIST [29 h]; ELEC ENG [29 h] | 5,020.26 | 2007-03-30 | MAHONEY K | 1 | 1 | 1.2.1.6.4.3 | MIKE S |  | 07-026 |  |  |  |  |  |  |  |  |
| 121643020 |  | Review PSS Systems Safety Specificaiton (PSS) |  | 5d | 2006-12-01 | 2006-12-07 | 121643015 FS+10d | 377.75d | 0d | ELEC ENG [69.6 h] | 4,598.47 | 2006-12-07 | MAHONEY K | 1 | 1 | 1.2.1.6.4.3 | MIKE S |  |  |  |  |  |  |  |  |  |  |
| 121643050 |  | Construct and Test Eng Dev Beam Transport Monitor (PSS) |  | 136d | 2006-12-11 | 2007-06-29 | 9-070M FS+48d | 231.75d | 75d | SUPPLIES & MATERIALS; ELEC ENG [12.2 h]; ELEC TECH [12.2 h] | 1,482.65 | 2007-07-31 | MAHONEY K | 1 | 1 | 1.2.1.6.4.3 | MIKE S |  | 07-026 |  |  |  |  |  |  |  |  |
| 121643025 |  | Conduct Internal PSS Design & Safety Review (PSS) |  | 5d | 2006-12-15 | 2006-12-21 | 121643020 FS+5d, 121643015 | 377.75d | 93d | ELEC ENG [34.8 h] | 2,299.24 | 2006-12-21 | MAHONEY K | 1 | 1 | 1.2.1.6.4.3 | MIKE S |  |  |  |  |  |  |  |  |  |  |
| 121643070 |  | Prepare Baseline Cost Estimate (PSS) |  | 25d | 2007-03-09 | 2007-04-12 | 121643015, 121643035 FS-52d, 121643040, 121643010 FS-80d | 324.75d | 4d | MECH ENG [17.4 h]; ELEC ENG [69.6 h] | 5,575.88 | 2007-03-21 | MAHONEY K | 1 | 1 | 1.2.1.6.4.3 | MIKE S |  |  |  |  |  |  |  |  |  |  |
| 121643055 |  | Develop Cable Plant Design (PSS) |  | 64d | 2007-04-02 | 2007-06-29 | 121643015 FS+88d | 231.5d | 0d | ELEC ENG [12.2 h]; ELEC DES [8.68 h] | 1,148.29 | 2007-05-31 | MAHONEY K | 1 | 1 | 1.2.1.6.4.3 | MIKE S |  | 07-026 |  |  |  |  |  |  |  |  |
| 121643060 |  | Develop PSS Insertion Device Design (PSS) |  | 64d | 2007-04-02 | 2007-06-29 | 121643015 FS+88d | 156.75d | 0d | SCIENTIST [17.4 h]; MECH DES [7.8 h]; ELEC ENG [7.8 h]; ELEC DES [7.8 h]; MECH ENG [11.3 h] | 2,983.12 | 2007-05-03 | MAHONEY K | 1 | 1 | 1.2.1.6.4.3 | MIKE S |  | 07-026 |  |  |  |  |  |  |  |  |
| 121643065 |  | Define PSS BCM Requirements (PSS) |  | 64d | 2007-04-02 | 2007-06-29 | 9-070M FS+120d | 284.75d | 0d | ELEC ENG [20.88 h] | 1,297.07 | 2007-02-27 | MAHONEY K | 1 | 1 | 1.2.1.6.4.3 | MIKE S |  | 07-026 |  |  |  |  |  |  |  |  |
| 121643075 |  | Prepare Review Material (PSS) |  | 15d | 2007-04-09 | 2007-04-27 | 121643070 FS-8d, 121643080 FS-59d | 320.75d | 36d | OFFICE [43.6 h]; ELEC ENG [60.9 h] | 4,905.37 | 2007-04-23 | MAHONEY K | 1 | 1 | 1.2.1.6.4.3 | MIKE S |  |  |  |  |  |  |  |  |  |  |
| 121643080 |  | Develop Software Specification (PSS) |  | 59d | 2007-04-09 | 2007-06-29 | 9-070M FS+125d | 320.75d | 0d | ELEC ENG [17.4 h] | 1,080.89 | 2007-03-21 | MAHONEY K | 1 | 1 | 1.2.1.6.4.3 | MIKE S |  | 07-026 |  |  |  |  |  |  |  |  |
| 121643085 |  | Complete Design & Safety Review - External Reviewers (PSS) |  | 5d | 2007-05-14 | 2007-05-18 | 121643065 FS-34d, 121643025, 121643075 FS-26d | 284.75d | 128d | TRAVEL; OFFICE [43.6 h]; ELEC ENG [60.9 h] | 9,033.37 | 2007-03-23 | MAHONEY K | 1 | 1 | 1.2.1.6.4.3 | MIKE S |  |  |  |  |  |  |  |  |  |  |
| 121643010A |  | Define Programmable Electronics Specification (PSS) |  | 30.5d | 2007-10-01 | 2007-11-12 | 9-070M, 121643010 FS+63d | 465.5d |  | ELEC ENG [10.45 h] | 650.53 | 2006-10-13 | MAHONEY K | 1 | 1 | 1.2.1.6.4.3 | MIKE S |  | 07-026 |  |  |  |  |  |  |  |  |
| 121643045A |  | Design Beam Transport Monitor (PSS) |  | 85d | 2007-10-01 | 2008-02-08 | 121643045 FS+63d | 411d |  | ELEC ENG [29 h]; ELEC DES [28.8 h]; SCIENTIST [29 h] | 4,893.83 | 2007-03-30 | MAHONEY K | 1 | 1 | 1.2.1.6.4.3 | MIKE S |  | 07-026 |  |  |  |  |  |  |  |  |
| 121643055A |  | Develop Cable Plant Design (PSS) |  | 51.75d | 2007-10-01 | 2007-12-13 | 121643055 FS+63d | 231.5d | 200.25d | ELEC ENG [109.8 h]; ELEC DES [78.12 h] | 10,314.2 | 2007-05-31 | MAHONEY K | 1 | 1 | 1.2.1.6.4.3 | MIKE S |  | 07-026 |  |  |  |  |  |  |  |  |
| 121643060A |  | Develop PSS Insertion Device Design (PSS) |  | 75d | 2007-10-01 | 2008-01-25 | 121643060 FS+63d | 156.75d | 0d | MECH DES [23.4 h]; MECH ENG [33.9 h]; ELEC DES [23.4 h]; SCIENTIST [52.2 h]; ELEC ENG [23.4 h] | 8,839.79 | 2007-05-03 | MAHONEY K | 1 | 1 | 1.2.1.6.4.3 | MIKE S |  | 07-026 |  |  |  |  |  |  |  |  |
| 121643065A |  | Define PSS BCM Requirements (PSS) |  | 75d | 2007-10-01 | 2008-01-25 | 121643065 FS+63d, 9-070M FS+32d | 421d |  | ELEC ENG [83.52 h] | 5,198.28 | 2007-02-27 | MAHONEY K | 1 | 1 | 1.2.1.6.4.3 | MIKE S |  | 07-026 |  |  |  |  |  |  |  |  |
| 121643080A |  | Develop Software Specification (PSS) |  | 75d | 2007-10-01 | 2008-01-25 | 121643080 FS+63d | 421d |  | ELEC ENG [52.2 h] | 3,248.93 | 2007-03-21 | MAHONEY K | 1 | 1 | 1.2.1.6.4.3 | MIKE S |  | 07-026 |  |  |  |  |  |  |  |  |
| 121643090M |  | PSS Design 35% Complete (PSS) | milestone | 0d | 2008-01-25 | 2008-01-25 | 121643085 FS+39d, 121643060A, 121643060 | 156.75d | 0d |  |  | 2007-05-17 | MAHONEY K | 1 | 1 | 1.2.1.6.4.3 | MIKE S |  |  | 5 |  |  |  |  |  |  |  |
| 121643050A |  | Construct and Test Eng Dev Beam Transport Monitor (PSS) |  | 126.5d | 2008-01-28 | 2008-07-25 | 121643090M, 121643050 FS+63d | 156.75d | 0d | ELEC TECH [109.8 h]; SUPPLIES & MATERIALS; ELEC ENG [109.8 h] | 13,025.32 | 2007-07-31 | MAHONEY K | 1 | 1 | 1.2.1.6.4.3 | MIKE S |  | 07-026 |  |  |  |  |  |  |  |  |
| 121643100 |  | FY08 Develop PSS Detail Dsgn |  | 121.5d | 2008-04-09 | 2008-09-30 | 121643050A FS-75d | 157.75d | 0d | MECH ENG [76.84 h]; ELEC ENG [845.22 h]; ELEC TECH [230.51 h]; SCIENTIST [76.84 h]; ELEC DES [461.03 h] | 91,655.75 |  | MAHONEY K | 1 | 1 | 1.2.1.6.4.3 | MIKE S |  | 07-026 |  |  | 08-031 |  |  |  | EXP0809 |  |
| 121643100a |  | FY09 Develop PSS Detail Dsgn |  | 5d | 2008-10-01 | 2008-10-07 | 121643100 | 157.75d | 0d | ELEC TECH [9.49 h]; ELEC DES [18.97 h]; SCIENTIST [3.16 h]; MECH ENG [3.16 h]; ELEC ENG [34.78 h] | 3,892.07 |  | MAHONEY K | 1 | 1 | 1.2.1.6.4.3 | MIKE S |  | 07-026 |  |  | 08-031 |  |  |  | EXP0809 |  |
| 13643909LOEX |  | FY09 Mngmnt & Supprt Effort for PSS |  | 59d | 2008-10-01 | 2008-12-24 | 121642908LOE | 20d | 0d | OFFICE [5.71 h]; SR STAFF [1.9 h]; ELEC ENG [2.85 h]; ELEC DES [5.71 h] | 789.36 |  | MAHONEY K | 1 | 1 |  | MIKE S |  |  |  |  |  | 08-058 |  |  |  |  |
| 121643095M |  | Start P-#2 of PSS PED - FY08 | milestone | 0d | 2008-10-07 | 2008-10-07 | 121643055, 121643055A, 9-080M, 121643050, 121643050A FS-75d, 9-090M FS+4d | 31.25d | 0d |  |  |  | MAHONEY K | 1 | 1 | 1.2.1.6.4.3 | MIKE S |  |  | 6 |  | 08-031 |  |  |  |  |  |
| 121643105 |  | Develop PSS Mock-up & Test-bed |  | 58.5d | 2008-10-07 | 2009-01-07 | 121643095M | 31.25d | 0d | SUPPLIES & MATERIALS; ELEC TECH [200 h]; MECH TECH [40 h]; PROCUREMENT<$50K 60; ELEC ENG [160 h] | 60,796.5 |  | MAHONEY K | 1 | 1 | 1.2.1.6.4.3 | MIKE S |  | 07-026 |  |  | 08-031 |  |  |  |  |  |
| 121643115 |  | Develop Logic Specificaiton for Tagger/H-D (PSS) |  | 24d | 2008-10-07 | 2008-11-07 | 121643095M | 99.25d | 68d | ELEC ENG [80 h] | 5,138.4 |  | MAHONEY K | 1 | 1 | 1.2.1.6.4.3 | MIKE S |  | 07-026 |  |  | 08-031 |  |  |  |  |  |
| 121643145 |  | Develop QA Documentation (PSS) |  | 23d | 2008-10-16 | 2008-11-17 | 121643100a FS+6d | 179.5d | 148.25d | SR STAFF [80 h]; ELEC ENG [120 h]; ELEC DES [40 h]; ELEC TECH [80 h] | 20,987.6 |  | MAHONEY K | 1 | 1 | 1.2.1.6.4.3 | MIKE S |  | 07-026 |  |  | 08-031 |  |  |  |  |  |
| 121643110 |  | Develop New Logic Specification for CEBAF Segements (PSS) |  | 34.5d | 2009-01-07 | 2009-02-26 | 121643095M, 121643105 | 31.25d | 0d | ELEC ENG [120 h] | 7,707.6 |  | MAHONEY K | 1 | 1 | 1.2.1.6.4.3 | MIKE S |  | 07-026 |  |  | 08-031 |  |  |  |  |  |
| 121643170 |  | Pre-Constrctn Dsgn Review |  | 5.75d | 2009-01-22 | 2009-01-29 | 121643135 FS-110d | 135.5d | 104.25d |  |  |  | MAHONEY K | 1 | 1 | 1.2.1.6.4.3 | MIKE S |  | 07-026 |  | C | 08-031 |  |  |  |  |  |
| 121643120 |  | Develop Screen Specification (PSS) |  | 18.5d | 2009-02-26 | 2009-03-24 | 121643115, 121643110 FS-1d | 48.25d | 17d | ELEC ENG [80 h] | 5,138.4 |  | MAHONEY K | 1 | 1 | 1.2.1.6.4.3 | MIKE S |  | 07-026 |  |  | 08-031 |  |  |  |  |  |
| 121643125 |  | Develop PSS-EPICS Software Spec (PSS) |  | 35.5d | 2009-02-26 | 2009-04-16 | 121643110 FS-1d, 121643115 | 31.25d | 0d | PROCUREMENT<$50K 60; ELEC ENG [80 h]; COMP SCIENT [40 h] | 13,021.25 |  | MAHONEY K | 1 | 1 | 1.2.1.6.4.3 | MIKE S | 09-012 | 07-026 |  |  | 08-031 |  |  |  |  | 08-016 |
| 121643130 |  | Comp Detail Dsgn Review - External Reviewers (PSS) |  | 27.75d | 2009-04-16 | 2009-05-27 | 121643125, 121643100a, 121643120, 121643110 | 31.25d | 0d | TRAVEL; ELEC ENG [160 h]; SCIENTIST [40 h]; ELEC TECH [80 h]; ELEC DES [80 h]; OFFICE [80 h] | 25,118.53 |  | MAHONEY K | 1 | 1 | 1.2.1.6.4.3 | MIKE S |  | 07-026 |  |  | 08-031 |  |  |  |  |  |
| 121643135 |  | Update Dsgn Based on Review recommendations (PSS) |  | 23d | 2009-05-27 | 2009-06-29 | 121643130 | 31.25d | 0d | ELEC TECH [40 h]; ELEC DES [80 h]; ELEC ENG [80 h] | 10,423.6 |  | MAHONEY K | 1 | 1 | 1.2.1.6.4.3 | MIKE S |  | 07-026 |  |  | 08-031 |  |  |  |  |  |
| 121643140 |  | Develop Proc Packages (PSS)++ |  | 34.5d | 2009-06-29 | 2009-08-17 | 121643170, 121643145, 121643135 | 31.25d |  | MECH DES [40 h]; ELEC ENG [200 h]; ELEC TECH [120 h] | 19,420 |  | MAHONEY K | 1 | 1 | 1.2.1.6.4.3 | MIKE S |  | 07-026 |  |  | 08-031 |  |  |  |  |  |
| 121643175 |  | Re-Baseline Actuals Adjustment |  | 1d | 2013-08-30 | 2013-08-30 | 9-130M FS+227d | 20d |  | PROCUREMENT>$50K 69 NO ESCALATION | 25,753.46 |  | MAHONEY K | 1 | 1 |  | MIKE S |  |  |  |  |  |  | 13-014 | ADJ |  |  |

| ID | WBS | Activity | Type | Duration | Start | Finish | Predecessors | Total float | Free float | Resources | Cost | Planned FinishUDF | RESP - Responsibility | STRT%COMP for CM EVM | FNSH%COMP for CM EVM | WBS ASSIGNMENT | CAM RESPONSIBLE | CR 09-012 | Milestone Level | Profile change | CR 08-058 | CR 07-027 | CR 13-014 | ReBaseline Actuals Adjustment |
| --- | --- | --- | --- | --- | --- | --- | --- | --- | --- | --- | --- | --- | --- | --- | --- | --- | --- | --- | --- | --- | --- | --- | --- | --- |
|  | 4 | **1.2.1.6.4.4** |  |  |  |  |  |  |  |  |  |  |  |  |  |  |  |  |  |  |  |  |  |  |
|  | 5 | **1.2.1.6.5 INSERTABLE DUMP** |  |  | 2006-10-02 | 2013-08-30 |  |  |  |  |  |  |  |  |  |  |  |  |  |  |  |  |  |  |
| 12165007LOE |  | FY07 Management Effort for Dump Controls (INSERT DUMP) |  | 247d | 2006-10-02 | 2007-09-28 | 9-070M | 20d | 0d | ELEC ENG [11.48 h]; SR STAFF [11.6 h]; SCIENTIST [11.83 h] | 2,631.56 | 2007-09-28 | GARZA O | 1 | 1 | 1.2.1.6.5 | MIKE S | 09-012 |  |  |  |  |  |  |
| 12165010 |  | Define & Package System Layout (INSERT DUMP) |  | 30d | 2006-10-02 | 2006-11-10 | 9-070M | 326.5d | 0d | ELEC ENG [52.2 h]; SCIENTIST [52.2 h] | 6,799.57 | 2006-11-10 | GARZA O | 1 | 1 | 1.2.1.6.5 | MIKE S |  |  |  |  |  |  |  |
| 12165015 |  | Design Top-Level System Layout (INSERT DUMP) |  | 30d | 2006-11-29 | 2007-01-18 | 12165010 FS+10d | 326.5d | 0d | ELEC DES [113.1 h]; SCIENTIST [26 h]; ELEC ENG [113.1 h]; ELEC TECH [60.9 h] | 16,751.18 | 2007-01-18 | GARZA O | 1 | 1 | 1.2.1.6.5 | MIKE S |  |  |  |  |  |  |  |
| 12165016 |  | Preliminary Design & Safety Review (INSERT DUMP) |  | 1d | 2007-03-01 | 2007-03-01 | 12165015 FS+28d | 326.5d | 0d | COMP SCIENT [6.8 h]; ELEC ENG [6.8 h] | 843.14 | 2007-03-01 | GARZA O | 1 | 1 | 1.2.1.6.5 | MIKE S |  |  |  |  |  |  |  |
| 12165016M |  | Complete Preliminary Design & Safety Review for Dump Controls (INSERT DUMP) | milestone | 0d | 2007-03-01 | 2007-03-01 | 12165016 | 326.5d | 0d |  |  | 2007-03-01 | GARZA O | 1 | 1 | 1.2.1.6.5 | MIKE S |  | 5 |  |  |  |  |  |
| 12165020M |  | Ready to Baseline Milestone for Dump Controls (INSERT DUMP) | milestone | 0d | 2007-03-01 | 2007-03-01 | 12165016M, 12165015 FS+29d | 326.5d | 148d |  |  | 2007-03-01 | GARZA O | 1 | 1 | 1.2.1.6.5 | MIKE S |  | 6 |  |  |  |  |  |
| 12165026 |  | FY08 Comp Dump Sys Dsgn |  | 25d | 2007-10-01 | 2007-11-02 | 9-080M, 12165020M | 178.5d | 0d |  |  |  | GARZA O | 1 | 1 | 1.2.1.6.5 | MIKE S |  |  |  |  |  |  |  |
| 12165908LOE |  | FY08 Mngmnt Effort for Dump Controls |  | 248d | 2007-10-01 | 2008-09-30 | 12165007LOE, 9-080M | 20d | 0d | SR STAFF [80 h] | 7,972.8 |  | GARZA O | 1 | 1 | 1.2.1.6.5 | MIKE S | 09-012 |  |  |  |  |  |  |
| 12165027 |  | Pre-Constrctn Final Dsgn Review for Dump |  | 2.5d | 2007-11-05 | 2007-11-07 | 12165026 | 178.5d |  |  |  |  | GARZA O | 1 | 1 | 1.2.1.6.5 | MIKE S |  |  | C |  |  |  |  |
| 1365909LOEX |  | FY09 Mngmnt Effort for Dump |  | 59d | 2008-10-01 | 2008-12-24 | 12165908LOE | 20d | 0d | SR STAFF [0.95 h] | 97.7 |  | GARZA O | 1 | 1 |  | MIKE S |  |  |  | 08-058 |  |  |  |
| 12165030 |  | Compile Dump Sys Elect Prcrmnt Packages++ |  | 125d | 2009-01-05 | 2009-07-01 | 9-090M FS+60d, 12165027 | 63d |  | ELEC ENG [560 h]; ELEC TECH [200 h] | 44,002.8 |  | GARZA O | 1 | 1 | 1.2.1.6.5 | MIKE S |  |  |  |  | 07-027 |  |  |
| 12165035 |  | Compile Dump Systen Mech Prcrmnt Packages++ |  | 65d | 2009-02-18 | 2009-05-19 | 9-090M FS+90d, 12165027 | 93d |  | ELEC TECH [120 h]; ELEC ENG [440 h]; SUPPLIES & MATERIALS | 34,178.36 |  | GARZA O | 1 | 1 | 1.2.1.6.5 | MIKE S |  |  |  |  | 07-027 |  |  |
| 12165040 |  | Re-Baseline Actuals Adjustment |  | 1d | 2013-08-30 | 2013-08-30 | 9-130M FS+227d | 20d |  | PROCUREMENT>$50K 69 NO ESCALATION | -96,468.98 |  | GARZA O | 1 | 1 |  | MIKE S |  |  |  |  |  | 13-014 | ADJ |
|  | 6 | **1.2.1.6.6 VACUUM CONTROLS** |  |  | 2006-10-02 | 2013-08-30 |  |  |  |  |  |  |  |  |  |  |  |  |  |  |  |  |  |  |
| 12166007LOE |  | FY07 Management Effort for Vacuum (VAC CONT) |  | 247d | 2006-10-02 | 2007-09-28 | 9-070M | 20d | 0d | SR STAFF [34.8 h] | 3,466.55 | 2007-09-28 | GARZA O | 1 | 1 | 1.2.1.6.6 | MIKE S |  |  |  |  |  |  |  |
| 12166010 |  | Design Top Level System Layout (VAC CONT) |  | 22.5d | 2006-12-05 | 2007-01-12 | 9-070M FS+44d | 351.5d | 34d | ELEC TECH [17.6 h]; ELEC ENG [87 h] | 6,477.08 | 2007-01-12 | GARZA O | 1 | 1 | 1.2.1.6.6 | MIKE S |  |  |  |  |  |  |  |
| 12166015 |  | Define Vacuum System Interface Requirements (VAC CONT) |  | 22.5d | 2006-12-05 | 2007-01-12 | 9-070M FS+44d | 317.5d | 0d | COMP SCIENT [34.8 h] | 2,015.62 | 2007-01-12 | GARZA O | 1 | 1 | 1.2.1.6.6 | MIKE S |  |  |  |  |  |  |  |
| 12166020 |  | Preliminary Design & Safety Review (VAC CONT) |  | 1d | 2007-03-02 | 2007-03-05 | 12166015 FS+33d | 317.5d | 0d | ELEC ENG [6.96 h] | 459.85 | 2007-03-05 | GARZA O | 1 | 1 | 1.2.1.6.6 | MIKE S |  |  |  |  |  |  |  |
| 12166020M |  | Complete Preliminary Design & Safety Review Vauum Controls (VAC CONT) | milestone | 0d | 2007-03-05 | 2007-03-05 | 12166010, 12166020 | 317.5d | 0d |  |  | 2007-03-05 | GARZA O | 1 | 1 | 1.2.1.6.6 | MIKE S |  | 5 |  |  |  |  |  |
| 12166025M |  | Ready to baseline Vauum Controls (VAC CONT) | milestone | 0d | 2007-03-05 | 2007-03-05 | 12166015 FS+34d, 12166020M | 317.5d | 146.5d |  |  | 2007-03-05 | GARZA O | 1 | 1 | 1.2.1.6.6 | MIKE S |  | 6 |  |  |  |  |  |
| 12166026 |  | FY08 Comp Sys Dsgn (VAC CONT) |  | 25d | 2007-10-01 | 2007-11-02 | 12166025M, 9-080M | 171d | 0d |  |  |  | GARZA O | 1 | 1 | 1.2.1.6.6 | MIKE S |  |  |  |  |  |  |  |
| 12166908LOE |  | FY08 Mngmnt Effort for Vac (VAC CONT) |  | 248d | 2007-10-01 | 2008-09-30 | 12167007LOE, 9-080M, 12166007LOE | 20d | 0d | SR STAFF [40 h] | 3,986.4 |  | GARZA O | 1 | 1 | 1.2.1.6.6 | MIKE S |  |  |  |  |  |  |  |
| 12166027 |  | Pre-Constrctn Final Dsgn Review for Vac Controls |  | 10d | 2007-11-05 | 2007-11-16 | 12166026 | 171d |  |  |  |  | GARZA O | 1 | 1 | 1.2.1.6.6 | MIKE S |  |  | C |  |  |  |  |
| 1366909LOEX |  | FY09 Mngmnt Effort for SRFand ARC Vac Controls |  | 59d | 2008-10-01 | 2008-12-24 | 12166908LOE | 20d | 0d | SR STAFF [0.95 h] | 97.7 |  | GARZA O | 1 | 1 |  | MIKE S |  |  |  | 08-058 |  |  |  |
| 12166035 |  | Compile Vac Controls Sys Elect Procurements Packages++ |  | 130d | 2009-01-05 | 2009-07-09 | 12166027, 9-090M FS+60d | 58d |  | PROCUREMENT<$50K 60; ELEC TECH [120 h]; SUPPLIES & MATERIALS; ELEC ENG [240 h] | 30,031.93 |  | GARZA O | 1 | 1 | 1.2.1.6.6 | MIKE S |  |  |  |  | 07-027 |  |  |
| 12166040 |  | Re-Baseline Actuals Adjustment |  | 1d | 2013-08-30 | 2013-08-30 | 9-130M FS+227d | 20d |  | PROCUREMENT>$50K 69 NO ESCALATION | 7,830.46 |  | GARZA O | 1 | 1 |  | MIKE S |  |  |  |  |  | 13-014 | ADJ |

| ID | WBS | Activity | Type | Duration | Start | Finish | Predecessors | Total float | Free float | Resources | Cost | Planned FinishUDF | RESP - Responsibility | STRT%COMP for CM EVM | FNSH%COMP for CM EVM | WBS ASSIGNMENT | CAM RESPONSIBLE | CR 09-012 | Milestone Level | Profile change | CR 07-027 | CR 13-014 | ReBaseline Actuals Adjustment |
| --- | --- | --- | --- | --- | --- | --- | --- | --- | --- | --- | --- | --- | --- | --- | --- | --- | --- | --- | --- | --- | --- | --- | --- |
|  | 7 | **1.2.1.6.7 MAGNET INSTRUMENTATION** |  |  | 2006-10-02 | 2013-08-30 |  |  |  |  |  |  |  |  |  |  |  |  |  |  |  |  |  |
| 12167007LOE |  | FY07 Management Effort for Magnet Controls (MAG INSTR) |  | 247d | 2006-10-02 | 2007-09-28 | 9-070M | 20d | 0d | SR STAFF [34.8 h] | 3,466.55 | 2007-09-28 | GARZA O | 1 | 1 | 1.2.1.6.7 | MIKE S | 09-012 |  |  |  |  |  |
| 12167010 |  | Design Top-Level Magnet Control System Layout (MAG INSTR) |  | 22.5d | 2006-12-05 | 2007-01-12 | 9-070M FS+44d | 344d | 0d | ELEC ENG [34.8 h]; ELEC DES [34.8 h] | 3,864.54 | 2007-01-12 | GARZA O | 1 | 1 | 1.2.1.6.7 | MIKE S |  |  |  |  |  |  |
| 12167015 |  | Preliminary Design & Safety Review (MAG INSTR) |  | 1d | 2007-02-02 | 2007-02-05 | 12167010 FS+14d | 344d | 0d | ELEC ENG [6.96 h] | 459.85 | 2007-02-05 | GARZA O | 1 | 1 | 1.2.1.6.7 | MIKE S |  |  |  |  |  |  |
| 12167015M |  | Complete Preliminary Design & Safety Review Magnet Controls (MAG INSTR) | milestone | 0d | 2007-02-05 | 2007-02-05 | 12167015 | 344d | 0d |  |  | 2007-02-05 | GARZA O | 1 | 1 | 1.2.1.6.7 | MIKE S |  | 5 |  |  |  |  |
| 12167020M |  | Ready to Baseline Magnet Controls WBS (MAG INSTR) | milestone | 0d | 2007-02-05 | 2007-02-05 | 12167015M, 12167010 FS+15d | 344d | 165.5d |  |  | 2007-02-05 | GARZA O | 1 | 1 | 1.2.1.6.7 | MIKE S |  | 6 |  |  |  |  |
| 12167026 |  | FY08 Comp Sys Dsgn (MAG INSTR) |  | 25d | 2007-10-01 | 2007-11-02 | 12167020M, 9-080M | 178.5d | 0d |  |  |  | GARZA O | 1 | 1 | 1.2.1.6.7 | MIKE S |  |  |  |  |  |  |
| 12167027 |  | Pre-Constrctn Final Dsgn Review for Mag Instrmenttn |  | 2.5d | 2007-11-05 | 2007-11-07 | 12167026 | 178.5d |  |  |  |  | GARZA O | 1 | 1 | 1.2.1.6.7 | MIKE S |  |  | C |  |  |  |
| 12167028 |  | Compile Mag Control Sys Elect Prcrmnt Package+ |  | 21.5d | 2009-01-05 | 2009-02-04 | 9-090M FS+60d, 12167027 | 166.5d |  | ELEC TECH [40 h]; ELEC ENG [40 h] | 4,176 |  | GARZA O | 1 | 1 | 1.2.1.6.7 | MIKE S |  |  |  | 07-027 |  |  |
| 12167030 |  | Re-Baseline Actuals Adjustment |  | 1d | 2013-08-30 | 2013-08-30 | 9-130M FS+227d | 20d |  | PROCUREMENT>$50K 69 NO ESCALATION | 844.63 |  | GARZA O | 1 | 1 |  | MIKE S |  |  |  |  | 13-014 | ADJ |
|  | 7 | **1.2.1.7** |  |  |  |  |  |  |  |  |  |  |  |  |  |  |  |  |  |  |  |  |  |
|  | 2 | **1.2.2 UPGRADE HALLS A, B & C** |  |  | 2006-10-02 | 2013-08-30 |  |  |  |  |  |  |  |  |  |  |  |  |  |  |  |  |  |
| 122030M |  | Monthly Safety Inspection Completed | milestone | 0d | 2006-10-31 | 2006-10-31 | 9-070M FS+22d | 475d | 0d |  |  | 2006-10-31 | ENT R | 1 | 1 |  | ROLF E |  | 4 |  |  |  |  |
| 122031M |  | Monthly Safety Inspection Completed | milestone | 0d | 2006-11-30 | 2006-11-30 | 122030M FS+20d | 475d | 0d |  |  | 2006-11-30 | ENT R | 1 | 1 |  | ROLF E |  | 4 |  |  |  |  |
| 122005M |  | Quarterly Safety Meeting Complete | milestone | 0d | 2006-12-22 | 2006-12-22 | 9-070M FS+58d | 475d | 0d |  |  | 2006-12-22 | ENT R | 1 | 1 |  | ROLF E |  | 4 |  |  |  |  |
| 122032M |  | Monthly Safety Inspection Completed | milestone | 0d | 2006-12-22 | 2006-12-22 | 122031M FS+16d | 475d | 0d |  |  | 2006-12-22 | ENT R | 1 | 1 |  | ROLF E |  | 4 |  |  |  |  |
| 122033M |  | Monthly Safety Inspection Completed | milestone | 0d | 2007-01-31 | 2007-01-31 | 122032M FS+21d | 475d | 0d |  |  | 2007-01-31 | ENT R | 1 | 1 |  | ROLF E |  | 4 |  |  |  |  |
| 122034M |  | Monthly Safety Inspection Completed | milestone | 0d | 2007-02-28 | 2007-02-28 | 122033M FS+19d | 475d | 0d |  |  | 2007-02-28 | ENT R | 1 | 1 |  | ROLF E |  | 4 |  |  |  |  |
| 122010M |  | Quarterly Safety Meeting Complete | milestone | 0d | 2007-03-30 | 2007-03-30 | 122005M FS+62d | 475d | 0d |  |  | 2007-03-30 | ENT R | 1 | 1 |  | ROLF E |  | 4 |  |  |  |  |
| 122035M |  | Monthly Safety Inspection Completed | milestone | 0d | 2007-03-30 | 2007-03-30 | 122034M FS+22d | 475d | 0d |  |  | 2007-03-30 | ENT R | 1 | 1 |  | ROLF E |  | 4 |  |  |  |  |
| 122036M |  | Monthly Safety Inspection Completed | milestone | 0d | 2007-04-30 | 2007-04-30 | 122035M FS+21d | 475d | 0d |  |  | 2007-04-30 | ENT R | 1 | 1 |  | ROLF E |  | 4 |  |  |  |  |
| 122037M |  | Monthly Safety Inspection Completed | milestone | 0d | 2007-05-31 | 2007-05-31 | 122036M FS+22d | 475d | 0d |  |  | 2007-05-31 | ENT R | 1 | 1 |  | ROLF E |  | 4 |  |  |  |  |
| 122015M |  | Quarterly Safety Meeting Complete | milestone | 0d | 2007-06-29 | 2007-06-29 | 122010M FS+64d | 475d | 0d |  |  | 2007-06-29 | ENT R | 1 | 1 |  | ROLF E |  | 4 |  |  |  |  |
| 122038M |  | Monthly Safety Inspection Completed | milestone | 0d | 2007-06-29 | 2007-06-29 | 122037M FS+21d | 475d | 0d |  |  | 2007-06-29 | ENT R | 1 | 1 |  | ROLF E |  | 4 |  |  |  |  |
| 122039M |  | Monthly Safety Inspection Completed | milestone | 0d | 2007-07-31 | 2007-07-31 | 122038M FS+21d | 475d | 0d |  |  | 2007-07-31 | ENT R | 1 | 1 |  | ROLF E |  | 4 |  |  |  |  |
| 122040M |  | Monthly Safety Inspection Completed | milestone | 0d | 2007-08-31 | 2007-08-31 | 122039M FS+23d | 475d | 0d |  |  | 2007-08-31 | ENT R | 1 | 1 |  | ROLF E |  | 4 |  |  |  |  |
| 122020M |  | Quarterly Sfty Meet Comp | milestone | 0d | 2007-09-28 | 2007-09-28 | 122015M FS+63d | 475d | 185d |  |  | 2007-09-28 | ENT R | 1 | 1 |  | ROLF E |  | 6 |  |  |  |  |
| 122041M |  | Monthly Sfty Inspection Comptd | milestone | 0d | 2007-09-28 | 2007-09-28 | 122040M FS+19d | 475d | 185d |  |  | 2007-09-28 | ENT R | 1 | 1 |  | ROLF E |  | 6 |  |  |  |  |

| ID | WBS | Activity | Type | Duration | Start | Finish | Predecessors | Total float | Free float | Resources | Cost | Planned FinishUDF | RESP - Responsibility | STRT%COMP for CM EVM | FNSH%COMP for CM EVM | Milestone Level | WBS ASSIGNMENT | CAM RESPONSIBLE | CR 09-012 | CR 13-014 | ReBaseline Actuals Adjustment |
| --- | --- | --- | --- | --- | --- | --- | --- | --- | --- | --- | --- | --- | --- | --- | --- | --- | --- | --- | --- | --- | --- |
|  | 1 | **1.2.2.1 HALL A** |  |  | 2006-10-02 | 2013-08-30 |  |  |  |  |  |  |  |  |  |  |  |  |  |  |  |
|  | 1 | **1.2.2.1.1 MAGNET** |  |  |  |  |  |  |  |  |  |  |  |  |  |  |  |  |  |  |  |
|  | 1 | **1.2.2.1.1.1 COMBINED FUNCTION MAGNET** |  |  |  |  |  |  |  |  |  |  |  |  |  |  |  |  |  |  |  |
|  | 2 | **1.2.2.1.1.2 CRYOGENIC SYSTEM** |  |  |  |  |  |  |  |  |  |  |  |  |  |  |  |  |  |  |  |
|  | 3 | **1.2.2.1.1.3 POWER SUPPLY** |  |  |  |  |  |  |  |  |  |  |  |  |  |  |  |  |  |  |  |
|  | 4 | **1.2.2.1.1.4 SHIELD HOUSE** |  |  |  |  |  |  |  |  |  |  |  |  |  |  |  |  |  |  |  |
|  | 5 | **1.2.2.1.1.5 SUPPORT STRUCTURE & MOTION SYSTEM** |  |  |  |  |  |  |  |  |  |  |  |  |  |  |  |  |  |  |  |
|  | 6 | **1.2.2.1.1.6 CONTROL SYSTEM** |  |  |  |  |  |  |  |  |  |  |  |  |  |  |  |  |  |  |  |
|  | 7 | **1.2.2.1.1.7 SEPTUM** |  |  |  |  |  |  |  |  |  |  |  |  |  |  |  |  |  |  |  |
|  | 2 | **1.2.2.1.2 DETECTORS** |  |  |  |  |  |  |  |  |  |  |  |  |  |  |  |  |  |  |  |
|  | 1 | **1.2.2.1.2.1 TRIGGER SYSTEM (Scintillators)** |  |  |  |  |  |  |  |  |  |  |  |  |  |  |  |  |  |  |  |
|  | 2 | **1.2.2.1.2.2 TRACKING SYSTEM (Drift Chambers)** |  |  |  |  |  |  |  |  |  |  |  |  |  |  |  |  |  |  |  |
|  | 3 | **1.2.2.1.2.3 GAS CERENKOV** |  |  |  |  |  |  |  |  |  |  |  |  |  |  |  |  |  |  |  |
|  | 4 | **1.2.2.1.2.4 AREOGEL CERENKOV** |  |  |  |  |  |  |  |  |  |  |  |  |  |  |  |  |  |  |  |
|  | 5 | **1.2.2.1.2.5 CALORIMETER** |  |  |  |  |  |  |  |  |  |  |  |  |  |  |  |  |  |  |  |
|  | 6 | **1.2.2.1.2.6 FOCAL PLANE POLARIMETER** |  |  |  |  |  |  |  |  |  |  |  |  |  |  |  |  |  |  |  |
|  | 3 | **1.2.2.1.3 COMPUTING** |  |  | 2006-10-02 | 2013-08-30 |  |  |  |  |  |  |  |  |  |  |  |  |  |  |  |
|  | 1 | **1.2.2.1.3.1 DAQ FOR MAD** |  |  |  |  |  |  |  |  |  |  |  |  |  |  |  |  |  |  |  |
|  | 2 | **1.2.2.1.3.2 DAQ UPGRADES FOR HRS** |  |  | 2006-10-02 | 2013-08-30 |  |  |  |  |  |  |  |  |  |  |  |  |  |  |  |
| 122132005M |  | Start PED DAQ upgrade for one HRS (DAQ UPGRD) | milestone | 0d | 2006-10-02 | 2006-10-02 | 9-070M | 637d | 0d |  |  | 2006-10-02 | LEROSE J | 1 | 1 | 6 | 1.2.2.1.3.2 | JOHN L |  |  |  |
| 122132010 |  | Specify readout modules & busses trigger changes. Design power dist changes. Engineer DAQ driver changes (DAQ UPGRD) |  | 85d | 2006-10-02 | 2007-02-08 | 122132005M | 637d | 347d | ELEC ENG [40 h]; ELEC DES [40 h]; PROCUREMENT<$50K 60; SCIENTIST [416 h] | 46,625.04 | 2007-02-08 | LEROSE J | 1 | 1 |  | 1.2.2.1.3.2 | JOHN L | 09-012 |  |  |
| 122132908LOE |  | FY08 Proj Admin H-A |  | 248d | 2007-10-01 | 2008-09-30 | 9-080M, 1252007LOE | 20d | 0d | SCIENTIST [88 h] | 5,479.76 |  | LEROSE J | 1 | 1 |  | 1.2.2.1.3.2 | JOHN L |  |  |  |
| 122132015 |  | Re-Baseline Actuals Adjustment |  | 1d | 2013-08-30 | 2013-08-30 | 9-130M FS+227d | 20d |  | PROCUREMENT>$50K 69 NO ESCALATION | 10,124 |  | LEROSE J | 1 | 1 |  |  | JOHN L |  | 13-014 | ADJ |
|  | 4 | **1.2.2.1.4 FAST ELECTRONICS** |  |  |  |  |  |  |  |  |  |  |  |  |  |  |  |  |  |  |  |
|  | 5 | **1.2.2.1.5 BEAMLINE** |  |  | 2006-10-02 | 2013-08-30 |  |  |  |  |  |  |  |  |  |  |  |  |  |  |  |
|  | 1 | **1.2.2.1.5.1 MOLLER POLARIMETER UPGRADE** |  |  | 2006-10-02 | 2013-08-30 |  |  |  |  |  |  |  |  |  |  |  |  |  |  |  |
| 122151005M |  | Start PED Moller (MLLR PLRMTR UPGRD) | milestone | 0d | 2006-10-02 | 2006-10-02 | 9-070M | 637d | 0d |  |  | 2006-10-02 | LEROSE J | 1 | 1 | 6 | 1.2.2.1.5.1 | JOHN L |  |  |  |
| 122151010 |  | Design dipole/detector stands beamline changes dipole insert (MLLR PLRMTR UPGRD) |  | 85d | 2006-10-02 | 2007-02-08 | 122151005M | 637d | 347d | VISTNG USERS [160 h]; MECH DES [240 h]; ELEC DES [40 h]; PLABOR; SCIENTIST [160 h] | 27,052.4 | 2007-02-08 | LEROSE J | 1 | 1 |  | 1.2.2.1.5.1 | JOHN L |  |  |  |
| 122151015 |  | Re-Baseline Actuals Adjustment |  | 1d | 2013-08-30 | 2013-08-30 | 9-130M FS+227d | 20d |  | PROCUREMENT>$50K 69 NO ESCALATION | -10,167.15 |  | LEROSE J | 1 | 1 |  |  | JOHN L |  | 13-014 | ADJ |

| ID | WBS | Activity | Type | Duration | Start | Finish | Predecessors | Total float | Free float | Resources | Cost | Planned FinishUDF | RESP - Responsibility | STRT%COMP for CM EVM | FNSH%COMP for CM EVM | Milestone Level | WBS ASSIGNMENT | CAM RESPONSIBLE | CR 07-027 | CR 13-014 | ReBaseline Actuals Adjustment | CR 08-010 | CR 09-012 | CR 07-002 | CR 07-012 | 12 GeV 4th level Critical Path | CR 07-025 | CR 07-024 | CR 08-011 | CR 08-016 | CR 11-022 | CR 11-026 | CR 11-035 | CR 13-002 | CR 08-058 | CR 11-005 |
| --- | --- | --- | --- | --- | --- | --- | --- | --- | --- | --- | --- | --- | --- | --- | --- | --- | --- | --- | --- | --- | --- | --- | --- | --- | --- | --- | --- | --- | --- | --- | --- | --- | --- | --- | --- | --- |
|  | 2 | **1.2.2.1.5.2 COMPTON POLARIMETER UPGRADE** |  |  | 2007-03-01 | 2013-08-30 |  |  |  |  |  |  |  |  |  |  |  |  |  |  |  |  |  |  |  |  |  |  |  |  |  |  |  |  |  |  |
| 122152005M |  | Start FY07 PED Compton - 1st phase | milestone | 0d | 2007-03-01 | 2007-03-01 | 9-070M FS+98d | 539d | 0d |  |  | 2007-03-01 | LEROSE J | 1 | 1 | 6 | 1.2.2.1.5.2 | JOHN L |  |  |  |  |  |  |  |  |  |  |  |  |  |  |  |  |  |  |
| 122152010 |  | FY07 Design magnets / cavity stands. Engineer detector mods (COMPT PLRMTR UPGRD) |  | 85d | 2007-03-01 | 2007-06-28 | 122152005M | 539d | 249d | MECH ENG [80 h]; MECH DES [120 h]; SCIENTIST [160 h]; PD UNIV STUDNT [400 h] | 24,340.63 | 2007-06-28 | LEROSE J | 1 | 1 |  | 1.2.2.1.5.2 | JOHN L |  |  |  |  |  |  |  |  |  |  |  |  |  |  |  |  |  |  |
| 122152015M |  | Start FY08 Milestone P-#2 (COMPT PLRMTR UPGRD) | milestone | 0d | 2008-07-02 | 2008-07-02 | 122041M, 122151010, 9-080M FS+185d, 122132010, 122020M, 122152010 | 290d | 0d |  |  |  | LEROSE J | 1 | 1 | 6 | 1.2.2.1.5.2 | JOHN L | 07-027 |  |  |  |  |  |  |  |  |  |  |  |  |  |  |  |  |  |
| 122152020 |  | FY08 Dsgn Vac Pipe & Detector motion Sys (COMPT PLRMTR UPGRD)+ |  | 21d | 2008-07-02 | 2008-07-31 | 122152015M | 290d |  | PD UNIV STUDNT [400 h]; MECH ENG [80 h]; SCIENTIST [160 h]; MECH DES [120 h] | 23,772 |  | LEROSE J | 1 | 1 |  | 1.2.2.1.5.2 | JOHN L | 07-027 |  |  |  |  |  |  |  |  |  |  |  |  |  |  |  |  |  |
| 122152025 |  | Re-Baseline Actuals Adjustment |  | 1d | 2013-08-30 | 2013-08-30 | 9-130M FS+227d | 20d |  | PROCUREMENT>$50K 69 NO ESCALATION | 27,306.32 |  | LEROSE J | 1 | 1 |  |  | JOHN L |  | 13-014 | ADJ |  |  |  |  |  |  |  |  |  |  |  |  |  |  |  |
|  | 3 | **1.2.2.1.5.3 MAPPING-ARC ENERGY MEASUREMENT** |  |  | 2006-10-02 | 2013-08-30 |  |  |  |  |  |  |  |  |  |  |  |  |  |  |  |  |  |  |  |  |  |  |  |  |  |  |  |  |  |  |
| 122153000M |  | Start FY07 PED 9th dipole mapper 1ST Phase | milestone | 0d | 2006-10-02 | 2006-10-02 | 9-070M | 543d | 0d |  |  | 2007-03-13 | LEROSE J | 1 | 1 | 6 | 1.2.2.1.5.3 | JOHN L |  |  |  |  |  |  |  |  |  |  |  |  |  |  |  |  |  |  |
| 122153005 |  | FY07 PED Engineer & analysis of mapping coil 1st Phase |  | 25d | 2006-10-02 | 2006-11-03 | 122153000M | 543d | 470d | MECH ENG [77.6 h]; ELEC DES [19.2 h]; SUPPLIES & MATERIALS; SCIENTIST [96.8 h]; MECH DES [155.2 h]; ELEC ENG [19.2 h]; TRAVEL | 24,628.35 | 2007-06-05 | LEROSE J | 1 | 1 |  | 1.2.2.1.5.3 | JOHN L | 07-027 |  |  |  |  |  |  |  |  |  |  |  |  |  |  |  |  |  |
| 122153009M |  | Start FY08 PED 9th Dipole Mapper P-#2 | milestone | 0d | 2008-10-01 | 2008-10-01 | 122153005, 9-090M | 73d | 0d |  |  |  | LEROSE J | 1 | 1 | 6 | 1.2.2.1.5.3 | JOHN L | 07-027 |  |  |  |  |  |  |  |  |  |  |  |  |  |  |  |  |  |
| 122153010 |  | PED Mech & Elect Sys Dsgn P-2+ |  | 70d | 2009-03-11 | 2009-06-17 | 122153009M FS+105d | 73d |  | MECH DES [40 h] | 1,753.6 |  | LEROSE J | 1 | 1 |  | 1.2.2.1.5.3 | JOHN L | 07-027 |  |  | 08-010 | 09-012 |  |  |  |  |  |  |  |  |  |  |  |  |  |
| 122153015 |  | Re-Baseline Actuals Adjustment |  | 1d | 2013-08-30 | 2013-08-30 | 9-130M FS+227d | 20d |  | PROCUREMENT>$50K 69 NO ESCALATION | -25,126.01 |  | LEROSE J | 1 | 1 |  |  | JOHN L |  | 13-014 | ADJ |  |  |  |  |  |  |  |  |  |  |  |  |  |  |  |
|  | 6 | **1.2.2.1.6 INFRASTRUCTURE** |  |  |  |  |  |  |  |  |  |  |  |  |  |  |  |  |  |  |  |  |  |  |  |  |  |  |  |  |  |  |  |  |  |  |
|  | 1 | **1.2.2.1.6.1 ENGINEERING & DESIGN** |  |  |  |  |  |  |  |  |  |  |  |  |  |  |  |  |  |  |  |  |  |  |  |  |  |  |  |  |  |  |  |  |  |  |
|  | 2 | **1.2.2.1.6.2 CABLING** |  |  |  |  |  |  |  |  |  |  |  |  |  |  |  |  |  |  |  |  |  |  |  |  |  |  |  |  |  |  |  |  |  |  |
|  | 3 | **1.2.2.1.6.3 INSTALLATION** |  |  |  |  |  |  |  |  |  |  |  |  |  |  |  |  |  |  |  |  |  |  |  |  |  |  |  |  |  |  |  |  |  |  |
|  | 2 | **1.2.2.2 HALL B** |  |  | 2006-10-02 | 2013-08-30 |  |  |  |  |  |  |  |  |  |  |  |  |  |  |  |  |  |  |  |  |  |  |  |  |  |  |  |  |  |  |
|  | 1 | **1.2.2.2.1 MAGNET** |  |  | 2006-10-02 | 2013-08-30 |  |  |  |  |  |  |  |  |  |  |  |  |  |  |  |  |  |  |  |  |  |  |  |  |  |  |  |  |  |  |
| 122211007LOE |  | FY07 Project Management for all Hall B |  | 247d | 2006-10-02 | 2007-09-28 | 9-070M | 20d | 0d | SCIENTIST [520 h] | 32,781.24 | 2007-09-28 | ELOUADRHIRI L | 1 | 1 |  | 1.2.2.2.1 | LATIFA E |  |  |  |  | 09-012 | 07-002 | 07-012 |  |  |  |  |  |  |  |  |  |  |  |
| 122211015M |  | Torus- Completion of ACD technical review and summary report | milestone | 0d | 2007-04-26 | 2007-04-26 | 9-070M FS+139d | 127d | 0d |  |  | 2007-04-26 | ELOUADRHIRI L | 1 | 1 | 5 | 1.2.2.2.1 | LATIFA E |  |  |  |  |  | 07-002 | 07-012 | 4 |  |  |  |  |  |  |  |  |  |  |
| 122212015M |  | Sol- Completion of ACD technical review and progress report | milestone | 0d | 2007-04-26 | 2007-04-26 | 9-070M FS+139d | 24.08d | 0d |  |  | 2007-04-26 | ELOUADRHIRI L | 1 | 1 | 5 | 1.2.2.2.1 | LATIFA E |  |  |  |  |  | 07-002 | 07-012 |  |  |  |  |  |  |  |  |  |  |  |
| 122211017 |  | Torus- Initial Payment for the design (TOROIDAL MAG) |  | 25d | 2007-04-27 | 2007-06-01 | 122211015M | 127d | 0d |  |  | 2007-04-27 | ELOUADRHIRI L | 1 | 1 |  | 1.2.2.2.1 | LATIFA E | 07-027 |  |  |  | 09-012 | 07-002 | 07-012 | 4 | 07-025 |  |  |  |  |  |  |  |  |  |
| 122212017 |  | Sol- Initial Payment for the design (SACLAY) |  | 25d | 2007-04-27 | 2007-06-01 | 122212015M | 24.08d | 0d | PROCUREMENT>$50K 69; PROCUREMENT<$50K 60 | 78,790 | 2007-04-27 | ELOUADRHIRI L | 1 | 1 |  | 1.2.2.2.1 | LATIFA E | 07-027 |  |  |  |  | 07-002 | 07-012 |  | 07-025 |  |  |  |  |  |  |  |  |  |
| 122211020 |  | Torus- First phase of the design (TOROIDAL MAG) |  | 65d | 2007-06-04 | 2007-09-04 | 122211017, 122211015M | 127d | 0d | PROCUREMENT>$50K 69; MECH DES [252 h]; MECH ENG [160 h]; PROCUREMENT<$50K 60 | 62,656.21 | 2007-07-31 | ELOUADRHIRI L | 1 | 1 |  | 1.2.2.2.1 | LATIFA E |  |  |  |  |  | 07-002 | 07-012 | 4 |  | 07-024 |  |  |  |  |  |  |  |  |
| 122212020 |  | Sol- First phase of the design (SOLENOID) |  | 65d | 2007-06-04 | 2007-09-04 | 122212017 | 24.08d | 0d | MECH DES [44 h]; PROCUREMENT<$50K 60; MECH ENG [28.4 h]; PROCUREMENT>$50K 69 | 38,976.62 | 2007-07-31 | ELOUADRHIRI L | 1 | 1 |  | 1.2.2.2.1 | LATIFA E | 07-027 |  |  |  |  | 07-002 | 07-012 |  |  |  |  |  |  |  |  |  |  |  |
| 122211025M |  | Torus- Safety Assessment (TOROIDAL MAG) | milestone | 0d | 2007-09-04 | 2007-09-04 | 122211020 | 127d | 0d |  |  |  | ELOUADRHIRI L | 1 | 1 | 5 | 1.2.2.2.1 | LATIFA E | 07-027 |  |  |  |  | 07-002 | 07-012 | 4 |  |  |  |  |  |  |  |  |  |  |
| 122212025M |  | Sol- Safety Assessment (SOLENOID) | milestone | 0d | 2007-09-04 | 2007-09-04 | 122212020 | 24.08d | 0d |  |  | 2007-07-31 | ELOUADRHIRI L | 1 | 1 | 5 | 1.2.2.2.1 | LATIFA E | 07-027 |  |  |  |  | 07-002 | 07-012 |  |  |  |  |  |  |  |  |  |  |  |
| 122211035 |  | **Torus-FY07-Second phase of the design (1st & part of 2nd prog pymnt) |  | 40d | 2007-09-05 | 2007-10-30 | 122211025M, 1131005 | 127d | 0d | MECH ENG [92 h]; MECH DES [184 h]; PROCUREMENT<$50K 60 NO ESCALATION FY08; PROCUREMENT>$50K 69 NO ESCALATION FY08 | 48,728.14 | 2007-09-28 | ELOUADRHIRI L | 1 | 1 |  | 1.2.2.2.1 | LATIFA E | 07-027 |  |  |  | 09-012 | 07-002 | 07-012 | 4 |  | 07-024 | 08-011 | 08-016 |  |  |  |  |  |  |
| 122212035 |  | **Solenoid- FY07 Contract for Design (1st & part of 2nd prog pymnt) |  | 19d | 2007-09-05 | 2007-10-01 | 122212020, 122212025M | 24.08d | 0d | MECH ENG [12 h]; MECH DES [28 h]; PROCUREMENT>$50K 69 NO ESCALATION FY08; PROCUREMENT<$50K 60 NO ESCALATION FY08 | 37,285.09 | 2007-09-28 | ELOUADRHIRI L | 1 | 1 |  | 1.2.2.2.1 | LATIFA E | 07-027 |  |  |  | 09-012 | 07-002 | 07-012 |  |  | 07-024 | 08-011 | 08-016 |  |  |  |  |  |  |
| 12221050 |  | **Solenoid- FY08 Contract for Design (part of 2nd prog pymnt) |  | 11.92d | 2007-10-02 | 2007-10-17 | 122212035 | 24.08d | 0d | MECH ENG [28 h]; PROCUREMENT<$50K 60; MECH DES [12 h] | 17,565 |  | ELOUADRHIRI L | 1 | 1 |  | 1.2.2.2.1 | LATIFA E |  |  |  |  |  |  |  |  |  |  | 08-011 |  |  |  |  |  |  |  |
| 12221050M |  | Solenoid- FY07 Techncl Dsgn Report & Sfty Assessmnt | milestone | 0d | 2007-10-17 | 2007-10-17 | 12221050 | 24.08d | 0d |  |  |  | ELOUADRHIRI L | 1 | 1 | 6 | 1.2.2.2.1 | LATIFA E |  |  |  |  |  |  |  |  |  |  |  |  |  |  |  |  |  |  |
| 12221055 |  | **Solenoid Labor Reference Dsgn |  | 75d | 2007-10-17 | 2008-02-13 | 12221050M, 122212036M FS-11d | 24.08d | 0d | SR STAFF [100 h]; MECH ENG [40 h]; MECH DES [40 h] | 14,138.8 |  | ELOUADRHIRI L | 1 | 1 |  | 1.2.2.2.1 | LATIFA E |  |  |  |  | 09-012 |  |  |  |  | 07-024 | 08-011 |  |  |  |  |  |  |  |
| 122211035M |  | Torus- FY07 Techncl Dsgn Report & Sfty Assessmnt | milestone | 0d | 2007-10-30 | 2007-10-30 | 122211035 | 127d | 0d |  |  | 2007-07-31 | ELOUADRHIRI L | 1 | 1 | 6 | 1.2.2.2.1 | LATIFA E |  |  |  |  |  | 07-002 | 07-012 | 4 |  |  |  |  |  |  |  |  |  |  |
| 12221040 |  | **Torus Labor Reference Dsgn |  | 85d | 2007-10-31 | 2008-03-12 | 122211036M FS-1d | 99d | 0d | MECH DES [40 h]; SR STAFF [100 h]; TRAVEL; MECH ENG [40 h] | 21,362.1 |  | ELOUADRHIRI L | 1 | 1 |  | 1.2.2.2.1 | LATIFA E |  |  |  |  | 09-012 |  |  | 4 |  | 07-024 | 08-011 |  |  |  |  |  |  |  |
| 122211036M |  | Torus- Contract Award | milestone | 0d | 2007-11-01 | 2007-11-01 | 9-080M FS+23d | 99d | 0d |  |  | 2007-04-26 | ELOUADRHIRI L | 1 | 1 | 5 | 1.2.2.2.1 | LATIFA E |  |  |  |  |  | 07-002 | 07-012 | 4 |  |  | 08-011 |  |  |  |  |  |  |  |
| 122211037S |  | **Torus- Contract for Design (balance of 2nd & 3rd progress pymnts) |  | 56d | 2007-11-01 | 2008-01-31 | 122211036M, 122211035M FS+1d | 127d | 0d | PROCUREMENT<$50K 60; PROCUREMENT>$50K 69 | 64,597.97 | 2007-04-27 | ELOUADRHIRI L | 1 | 1 |  | 1.2.2.2.1 | LATIFA E | 07-027 |  |  |  |  | 07-002 |  |  |  |  | 08-011 |  |  |  |  |  |  |  |
| 122212036M |  | Solenoid- Contract Award | milestone | 0d | 2007-11-01 | 2007-11-01 | 9-080M FS+23d | 25d | 0d |  |  | 2007-04-26 | ELOUADRHIRI L | 1 | 1 | 5 | 1.2.2.2.1 | LATIFA E |  |  |  |  |  | 07-002 | 07-012 | 4 |  |  | 08-011 |  |  |  |  |  |  |  |
| 122212037S |  | **Solenoid- Contract for Design (balance of 2nd & 3rd progress pymnts) |  | 97d | 2007-11-01 | 2008-03-31 | 122212036M | 86d | 0d | PROCUREMENT>$50K 69 | 49,247.28 | 2007-04-27 | ELOUADRHIRI L | 1 | 1 |  | 1.2.2.2.1 | LATIFA E | 07-027 |  |  |  | 09-012 | 07-002 |  |  |  |  | 08-011 |  |  |  |  |  |  |  |
| 122211038M |  | Torus- 1st Progress Payment Completed | milestone | 0d | 2007-11-29 | 2007-11-29 | 122211036M FS+19d, 122211035 | 148d | 0d |  |  | 2007-04-26 | ELOUADRHIRI L | 1 | 1 | 5 | 1.2.2.2.1 | LATIFA E |  |  |  |  |  | 07-002 | 07-012 | 4 |  |  | 08-011 |  |  |  |  |  |  |  |
| 122211039M |  | Torus- 2nd Progress Payment Completed | milestone | 0d | 2007-12-21 | 2007-12-21 | 122211038M FS+16d, 122211035 | 148d | 21d |  |  | 2007-04-26 | ELOUADRHIRI L | 1 | 1 | 5 | 1.2.2.2.1 | LATIFA E |  |  |  |  |  | 07-002 | 07-012 | 4 |  |  | 08-011 |  |  |  |  |  |  |  |
| 122212038M |  | Solenoid- 1st Progress Payment Completed | milestone | 0d | 2008-01-04 | 2008-01-04 | 122212035, 122212036M FS+38d | 107d | 0d |  |  | 2007-04-26 | ELOUADRHIRI L | 1 | 1 | 5 | 1.2.2.2.1 | LATIFA E |  |  |  |  |  | 07-002 | 07-012 | 4 |  |  | 08-011 |  |  |  |  |  |  |  |
| 122211040M |  | Torus- 3rd Progress Payment Completed | milestone | 0d | 2008-01-31 | 2008-01-31 | 122211037S, 122211039M | 127d | 28d |  |  | 2007-04-26 | ELOUADRHIRI L | 1 | 1 | 5 | 1.2.2.2.1 | LATIFA E |  |  |  |  |  | 07-002 | 07-012 | 4 |  |  | 08-011 |  |  |  |  |  |  |  |
| 12221060 |  | Solenoid Labor Procurement Prep |  | 155d | 2008-02-13 | 2008-09-23 | 12221055 | 24.08d | 5.08d | MECH DES [40 h]; MSHOP; MECH ENG [40 h]; SR STAFF [100 h] | 18,503.74 |  | ELOUADRHIRI L | 1 | 1 |  | 1.2.2.2.1 | LATIFA E |  |  |  |  | 09-012 |  |  |  |  | 07-024 | 08-011 |  | 11-022 | 11-026 | 11 -035 |  |  |  |
| 122212039M |  | Solenoid- 2nd Progress Payment Completed | milestone | 0d | 2008-02-29 | 2008-02-29 | 12221050, 122212035, 122212038M FS+38d | 107d | 21d |  |  | 2007-04-26 | ELOUADRHIRI L | 1 | 1 | 5 | 1.2.2.2.1 | LATIFA E |  |  |  |  |  | 07-002 | 07-012 | 4 |  |  | 08-011 |  |  |  |  |  |  |  |
| 12221045M |  | Torus- Reference Dsgn Comptd++ | milestone | 0d | 2008-03-12 | 2008-03-12 | 12221040, 122211040M | 99d | 56d |  |  |  | ELOUADRHIRI L | 1 | 1 | 6 | 1.2.2.2.1 | LATIFA E |  |  |  |  |  |  |  | 4 |  |  | 08-011 |  |  |  |  |  |  |  |
| 12221045 |  | Torus Labor Procurement Prep |  | 140d | 2008-03-13 | 2008-09-29 | 12221040 | 831d | 1d | SR STAFF [100 h]; TRAVEL; MECH ENG [40 h]; MSHOP; MECH DES [40 h] | 26,521.6 |  | ELOUADRHIRI L | 1 | 1 |  | 1.2.2.2.1 | LATIFA E |  |  |  |  | 09-012 |  |  | 4 |  | 07-024 | 08-011 |  |  | 11-026 | 11 -035 | 13-002F |  |  |
| 12221060M |  | Solenoid- Reference Dsgn Comptd++ | milestone | 0d | 2008-03-31 | 2008-03-31 | 122212040M, 12221055 | 86d | 43d |  |  |  | ELOUADRHIRI L | 1 | 1 | 6 | 1.2.2.2.1 | LATIFA E |  |  |  |  |  |  |  |  |  |  | 08-011 |  |  |  |  |  |  |  |
| 122212040M |  | Solenoid- 3rd Progress Payment Completed | milestone | 0d | 2008-03-31 | 2008-03-31 | 122212039M, 122212037S | 86d | 0d |  |  | 2007-04-26 | ELOUADRHIRI L | 1 | 1 | 5 | 1.2.2.2.1 | LATIFA E |  |  |  |  |  | 07-002 | 07-012 | 4 |  |  | 08-011 |  |  |  |  |  |  |  |
| 14211000MX |  | Torus Start 2nd Phase of Proc Prep | milestone | 0d | 2008-10-01 | 2008-10-01 | 9-090M, 12221045 | 830d | 0d |  |  |  | ELOUADRHIRI L | 1 | 1 | 6 |  | LATIFA E |  |  |  |  |  |  |  | 4 |  |  |  |  |  | 11-026 | 11 -035 | 13-002F | 08-058 |  |
| 14211002X |  | Torus Prcrmnt Prep |  | 59d | 2008-10-01 | 2008-12-24 | 14211000MX | 830d | 0d | OFFICE [80 h]; ELEC TECH [80 h]; SCIENTIST [280 h]; MECH ENG [360 h]; MECH TECH [800 h]; ELEC DES [280 h]; ELEC ENG [200 h]; MECH DES [240 h] | 114,858.4 |  | ELOUADRHIRI L | 1 | 1 |  |  | LATIFA E |  |  |  |  |  |  |  |  |  |  |  |  |  | 11-026 | 11 -035 | 13-002F | 08-058 |  |
| 14211009EX |  | Torus FY09 Travel |  | 59d | 2008-10-01 | 2008-12-24 | 9-090M | 0d |  | TRAVEL | 1,899.92 |  | ELOUADRHIRI L | 1 | 1 |  |  | LATIFA E |  |  |  |  |  |  |  |  |  | 07-024 |  |  |  |  |  |  | 08-058 |  |
| 14212000MX |  | Solenoid Start 2nd Phase of Proc Prep | milestone | 0d | 2008-10-01 | 2008-10-01 | 9-090M, 12221060 | 19d | 0d |  |  |  | ELOUADRHIRI L | 1 | 1 | 6 |  | LATIFA E |  |  |  |  |  |  |  |  |  |  |  |  | 11-022 | 11-026 | 11 -035 |  | 08-058 |  |
| 14212002X |  | Solenoid Prcrmnt Prep for Dsgn & Prcrmnt |  | 59d | 2008-10-01 | 2008-12-24 | 14212000MX, 12221060M | 19d | 0d | OFFICE [80 h]; MECH TECH [800 h]; MECH DES [200 h]; MECH ENG [200 h]; ELEC TECH [60 h]; ELEC ENG [20 h]; VISTNG USERS [160 h]; SCIENTIST [40 h] | 65,048 |  | ELOUADRHIRI L | 1 | 1 |  |  | LATIFA E |  |  |  |  |  |  |  |  |  |  |  |  | 11-022 | 11-026 | 11 -035 |  | 08-058 |  |
| 14212009EX |  | Solenoid FY09 Travel |  | 59d | 2008-10-01 | 2008-12-24 | 9-090M | 19d | 0d | TRAVEL | 1,899.92 |  | ELOUADRHIRI L | 1 | 1 |  |  | LATIFA E |  |  |  |  |  |  |  |  |  | 07-024 |  |  |  | 11-026 | 11 -035 |  | 08-058 | 11-005 |
| 122212050 |  | Re-Baseline Actuals Adjustment |  | 1d | 2013-08-30 | 2013-08-30 | 9-130M FS+227d | 20d |  | PROCUREMENT>$50K 69 NO ESCALATION | 57,340.69 |  | ELOUADRHIRI L | 1 | 1 |  |  | LATIFA E |  | 13-014 | ADJ |  |  |  |  |  |  |  |  |  |  |  |  |  |  |  |

Notes:
- 122211017: Corrective Actions: Reduced Over 50k Budget From $20,980 / To $18,735. Per Lyn Wells To Comply With CR 07-012. (PMC)
- 122212017: Corrective Actions: Reduced Over 50k Budget From $20,980 / To $18,735. Per Lyn Wells To Comply With CR 07-012. (PMC)
- 122211020: Corrective Actions: Reduced Over 50k Budget From $20,990 / To $18,740. Per Lyn Wells To Comply With CR 07-012. (PMC)
- 122212020: Corrective Actions: Reduced Over 50k Budget From $20,990 / To $18,740. Per Lyn Wells To Comply With CR 07-012. (PMC)
- 122211035: Corrective Actions: Reduced Over 50k Budget From $20,990 / To $18,740. Per Lyn Wells To Comply With CR 07-012. (PMC) / Explanation: Since this is an FY07 past history activity it can't / be changed, so the budget of this activity is considered to be the 1st PP / ($30,002) and part of the 2nd ($5,408 of total of $30,002 = / 18.0% of the 2nd PP / and 5.4% of total Torus Contract) progress payments on the Torus / contract.
- 122212035: Corrective Actions: Reduced Over 50k Budget From $20,990 / To $18,740. Per Lyn Wells To Comply With CR 07-012. (PMC) / Explanation: Since this is an FY07 past / history activity it can't be changed, so the budget of this activity is / considered to be the 1st PP ($29,994) and part of the 2nd ($5,416 of total of / $29,994 = / 18.1% of the 2nd PP and 5.4% / of total Solenoid contract) progress payments on the Solenoid contract.
- 12221050: Explanation: Since this is an FY07 past history activity it can't be changed, so the / budget of this activity is considered to be part of the 2nd ($14,850 of / total of $29,994 = 49.5% of 2nd PP and 14.8% of the / total Solenoid contract) progress payment on the Solenoid / contract.
- 122211037S: Corrective Actions: Reduced Over 50k Budget From $20,980 / To $18,735. Per Lyn Wells To Comply With CR 07-012. (PMC) / Steps: Balance of 2nd PP for Approved Torus Interim Design Report; 3rd PP for Approved Torus Final Reference Design Study
- 122212037S: Corrective Actions: Reduced Over 50k Budget From $20,980 / To $18,735. Per Lyn Wells To Comply With CR 07-012. (PMC) / Steps: Balance of 2nd PP Solenoid Interim Design Report Approved; 3rd PP Solenoid Final Reference Design Study Approved (3rd PP = 60% of this act = 40% of Solenoid Contract)
- 14211002X: Steps: Answer all pre bid questions; Initial Evaluation; Review of response/discussions1; Eval Final Round; Release best and final; Evaluate Best and Final; Award Contract
- 14212002X: Steps: Answer all pre bid questions; Evaluate proposal; Review of responses/discussions; Eval Final Round; Release best and final; Eval Best and Final; Award Contract

| ID | WBS | Activity | Type | Duration | Start | Finish | Predecessors | Total float | Free float | Resources | Cost | Planned FinishUDF | RESP - Responsibility | STRT%COMP for CM EVM | FNSH%COMP for CM EVM | CR 07-002 | WBS ASSIGNMENT | CAM RESPONSIBLE | CR 07-027 | Milestone Level | EXPNS ACT BRIDGING FY SPLIT | ACT BRIDGING FY SPLIT | CR 08-016 | CR 09-012 | CR 07-024 | CR 08-058 | CR 10-015 | CR 11-026 | CR 11-035 | CR 13-002 | CR 13-014 | ReBaseline Actuals Adjustment |
| --- | --- | --- | --- | --- | --- | --- | --- | --- | --- | --- | --- | --- | --- | --- | --- | --- | --- | --- | --- | --- | --- | --- | --- | --- | --- | --- | --- | --- | --- | --- | --- | --- |
|  | 1 | **1.2.2.2.1.1 TOROIDAL MAGNET** |  |  |  |  |  |  |  |  |  |  |  |  |  |  |  |  |  |  |  |  |  |  |  |  |  |  |  |  |  |  |
|  | 2 | **1.2.2.2.1.2 SOLENOID** |  |  |  |  |  |  |  |  |  |  |  |  |  |  |  |  |  |  |  |  |  |  |  |  |  |  |  |  |  |  |
|  | 2 | **1.2.2.2.2 DETECTORS** |  |  | 2006-10-02 | 2013-08-30 |  |  |  |  |  |  |  |  |  |  |  |  |  |  |  |  |  |  |  |  |  |  |  |  |  |  |
| 1222211005 |  | SVT-Design overall layout (SILICON DTCTR) |  | 150d | 2006-10-02 | 2007-05-11 | 9-070M | 228d | 0d | MECH ENG [92 h]; MECH DES [337.54 h] | 20,609.49 | 2007-03-16 | ELOUADRHIRI L | 1 | 1 | 07-002 | 1.2.2.2.2 | LATIFA E |  |  |  |  |  |  |  |  |  |  |  |  |  |  |
| 1222211015 |  | SVT- Design of the VME Board (SILICON DTCTR) |  | 125d | 2006-10-02 | 2007-04-06 | 9-070M | 268d | 0d | ELEC ENG [153.43 h]; ELEC DES [577.6 h] | 36,093 | 2007-04-06 | ELOUADRHIRI L | 1 | 1 | 07-002 | 1.2.2.2.2 | LATIFA E |  |  |  |  |  |  |  |  |  |  |  |  |  |  |
| 1222213005 |  | DC- Design of the chamber & Stringing Fixture : Phase 1 (F DRFT CHAMB) |  | 120d | 2006-10-02 | 2007-03-30 | 9-070M | 251d | 0d | MECH DES [245.48 h]; CONTRB UNIV LBR [214.79 h]; MECH ENG [92 h]; MECH TECH [245.48 h] | 26,329.24 | 2007-03-30 | ELOUADRHIRI L | 1 | 1 | 07-002 | 1.2.2.2.2 | LATIFA E |  |  |  |  |  |  |  |  |  |  |  |  |  |  |
| 1222213010 |  | DC-Design On-chamber Electronics: Phase 1 (F DRFT CHAMB) |  | 120d | 2006-10-02 | 2007-03-30 | 9-070M | 251d | 0d | OFFICE [214.79 h]; ELEC ENG [122.74 h]; ELEC DES [337.54 h]; ELEC TECH [122.74 h] | 33,913.06 | 2007-03-30 | ELOUADRHIRI L | 1 | 1 | 07-002 | 1.2.2.2.2 | LATIFA E |  |  |  |  |  |  |  |  |  |  |  |  |  |  |
| 1222223005 |  | Designing the mounting (FCAL) |  | 100d | 2006-10-02 | 2007-03-02 | 9-070M | 419d | 0d | MECH ENG [97.47 h]; MECH DES [123 h] | 11,472.34 | 2007-03-02 | ELOUADRHIRI L | 1 | 1 | 07-002 | 1.2.2.2.2 | LATIFA E | 07-027 |  |  |  |  |  |  |  |  |  |  |  |  |  |
| 1222223010 |  | Design Box with end plates (FCAL) |  | 100d | 2006-10-02 | 2007-03-02 | 9-070M | 419d | 0d | MECH DES [184.11 h]; MECH ENG [66.78 h] | 12,286.24 | 2007-03-02 | ELOUADRHIRI L | 1 | 1 | 07-002 | 1.2.2.2.2 | LATIFA E | 07-027 |  |  |  |  |  |  |  |  |  |  |  |  |  |
| 1222223025 |  | Design pmt holders fiber routing and light guides (FCAL) |  | 100d | 2006-10-02 | 2007-03-02 | 9-070M | 454d | 35d | MECH DES [184.11 h] | 8,161.6 | 2007-03-02 | ELOUADRHIRI L | 1 | 1 | 07-002 | 1.2.2.2.2 | LATIFA E | 07-027 |  |  |  |  |  |  |  |  |  |  |  |  |  |
| 1222231005 |  | Design of Light Guides (CTOF) |  | 120d | 2006-10-02 | 2007-03-30 | 9-070M | 383d | 58d | SCIENTIST [122.74 h]; MECH ENG [90.25 h]; MECH DES [158.8 h] | 20,492.12 | 2007-03-30 | ELOUADRHIRI L | 1 | 1 | 07-002 | 1.2.2.2.2 | LATIFA E | 07-027 |  |  |  |  |  |  |  |  |  |  |  |  |  |
| 1222232005 |  | Design of the backing structure for scintillators (FTOF) |  | 125d | 2006-10-02 | 2007-04-06 | 9-070M | 493d | 122d | SCIENTIST [122.74 h]; MECH ENG [61.37 h]; MECH DES [122.74 h] | 17,104.51 | 2007-04-06 | ELOUADRHIRI L | 1 | 1 | 07-002 | 1.2.2.2.2 | LATIFA E | 07-027 |  |  |  |  |  |  |  |  |  |  |  |  |  |
| 1222232010 |  | Design of the light guides (FTOF) |  | 125d | 2006-10-02 | 2007-04-06 | 9-070M | 493d | 0d | MECH DES [122.74 h]; SCIENTIST [122.74 h]; MECH ENG [61.37 h] | 17,104.51 | 2007-04-06 | ELOUADRHIRI L | 1 | 1 | 07-002 | 1.2.2.2.2 | LATIFA E | 07-027 |  |  |  |  |  |  |  |  |  |  |  |  |  |
| 1222223030 |  | Design lifting plan and hardware (FCAL) |  | 40d | 2006-11-15 | 2007-01-22 | 1222223015 FS-85d | 482d | 63d | MECH DES [61.37 h]; MECH ENG [66.78 h] | 6,845.17 | 2007-07-24 | ELOUADRHIRI L | 1 | 1 | 07-002 | 1.2.2.2.2 | LATIFA E | 07-027 |  |  |  |  |  |  |  |  |  |  |  |  |  |
| 1222223015 |  | Design scintillator holders (FCAL) |  | 60d | 2006-12-22 | 2007-03-27 | 1222223010 FS-43d, 1222223005 FS-43d | 419d | 0d | MECH DES [122.74 h]; MECH ENG [66.78 h] | 9,565.7 | 2007-05-25 | ELOUADRHIRI L | 1 | 1 | 07-002 | 1.2.2.2.2 | LATIFA E | 07-027 |  |  |  |  |  |  |  |  |  |  |  |  |  |
| 1222231010 |  | Design of tools for the LG bending technique (CTOF) |  | 120d | 2007-01-02 | 2007-06-21 | 9-070M FS+58d | 325d | 0d | MECH ENG [90.25 h]; SCIENTIST [122.74 h]; MECH DES [158.84 h] | 20,421.48 | 2007-06-21 | ELOUADRHIRI L | 1 | 1 | 07-002 | 1.2.2.2.2 | LATIFA E | 07-027 |  |  |  |  |  |  |  |  |  |  |  |  |  |
| 1222232015 |  | Magnetic shielding design (FTOF) |  | 125d | 2007-01-02 | 2007-06-28 | 9-070M FS+58d | 435d | 64d | SCIENTIST [122.74 h]; MECH ENG [61.37 h]; MECH DES [122.74 h] | 17,041.29 | 2007-06-28 | ELOUADRHIRI L | 1 | 1 | 07-002 | 1.2.2.2.2 | LATIFA E | 07-027 |  |  |  |  |  |  |  |  |  |  |  |  |  |
| 1222241005 |  | Design of the mirror 6 sectors (HTCC) |  | 120d | 2007-01-04 | 2007-06-25 | 9-070M FS+60d | 363d | 67d | MECH ENG [92 h]; SCIENTIST [184.11 h] | 17,452.99 | 2007-06-25 | ELOUADRHIRI L | 1 | 1 | 07-002 | 1.2.2.2.2 | LATIFA E | 07-027 |  |  |  |  |  |  |  |  |  |  |  |  |  |
| 1222242005 |  | Design modification to the mirrors (LTCC) |  | 110d | 2007-01-04 | 2007-06-11 | 9-070M FS+60d | 411d | 0d | VISTNG USERS [306.85 h] | 5,280.89 | 2007-06-11 | ELOUADRHIRI L | 1 | 1 | 07-002 | 1.2.2.2.2 | LATIFA E | 07-027 |  |  |  |  |  |  |  |  |  |  |  |  |  |
| 1222241010 |  | Design of the Module (HTCC) |  | 100d | 2007-01-24 | 2007-06-14 | 9-070M FS+73d | 296d | 0d | SCIENTIST [61.37 h]; MECH DES [521.64 h]; MECH ENG [30.8 h]; ELEC DES [30.8 h] | 30,169 | 2007-06-14 | ELOUADRHIRI L | 1 | 1 | 07-002 | 1.2.2.2.2 | LATIFA E | 07-027 |  |  |  |  |  |  |  |  |  |  |  |  |  |
| 1222231015 |  | Design the support for the triplet with 1 m long bend LG's (CTOF) |  | 84d | 2007-02-15 | 2007-06-14 | 9-070M FS+89d | 330d | 5d | SCIENTIST [122.74 h]; MECH ENG [61.37 h]; MECH DES [194.94 h] | 20,197.28 | 2007-09-28 | ELOUADRHIRI L | 1 | 1 | 07-002 | 1.2.2.2.2 | LATIFA E | 07-027 |  |  |  |  |  |  |  |  |  |  |  |  |  |
| 1222232020 |  | PMT housing and grounding design (FTOF) |  | 158d | 2007-02-15 | 2007-09-28 | 9-070M FS+89d | 371d | 0d | SCIENTIST [122.74 h]; MECH ENG [61.2 h]; MECH DES [122.74 h] | 16,656.81 | 2007-09-28 | ELOUADRHIRI L | 1 | 1 | 07-002 | 1.2.2.2.2 | LATIFA E | 07-027 |  |  |  |  |  |  |  |  |  |  |  |  |  |
| 1222242010 |  | Design of the support structure (LTCC) |  | 110d | 2007-03-21 | 2007-08-23 | 1222242005 FS-58d | 411d | 0d | MECH DES [306.85 h]; MECH ENG [31.6 h] | 15,097.47 | 2007-09-28 | ELOUADRHIRI L | 1 | 1 | 07-002 | 1.2.2.2.2 | LATIFA E | 07-027 |  |  |  |  |  |  |  |  |  |  |  |  |  |
| 1222223020 |  | Design lead sheets (FCAL) |  | 20d | 2007-03-26 | 2007-04-20 | 1222223015 FS-2d | 419d | 0d | MECH DES [18.05 h]; MECH ENG [46.8 h] | 3,692.23 | 2007-06-25 | ELOUADRHIRI L | 1 | 1 | 07-002 | 1.2.2.2.2 | LATIFA E | 07-027 |  |  |  |  |  |  |  |  |  |  |  |  |  |
| 1222213015 |  | DC- Design of the chamber & Stringing Fixture : Phase 2 (F DRFT CHAMB) |  | 127d | 2007-04-02 | 2007-09-28 | 1222213005 | 251d | 0d | MECH DES [245.48 h]; MECH TECH [245.48 h]; MECH ENG [92 h] | 25,619.69 | 2007-09-28 | ELOUADRHIRI L | 1 | 1 | 07-002 | 1.2.2.2.2 | LATIFA E |  |  |  |  |  |  |  |  |  |  |  |  |  |  |
| 1222213020 |  | DC-Design On-chamber Electronics: Phase 2 (F DRFT CHAMB) |  | 127d | 2007-04-02 | 2007-09-28 | 1222213010 | 251d | 0d | CONTRB UNIV LBR [245.48 h]; ELEC DES [337.6 h]; ELEC ENG [122.74 h]; ELEC TECH [122.74 h] | 27,122.85 | 2007-09-28 | ELOUADRHIRI L | 1 | 1 | 07-002 | 1.2.2.2.2 | LATIFA E |  |  |  |  |  |  |  |  |  |  |  |  |  |  |
| 1222211020 |  | SVT- Design readout software (SILICON DTCTR) |  | 122d | 2007-04-09 | 2007-09-28 | 1222211015 | 268d | 40d | ELEC ENG [184.11 h] | 11,265.38 | 2007-09-28 | ELOUADRHIRI L | 1 | 1 | 07-002 | 1.2.2.2.2 | LATIFA E |  |  |  |  |  |  |  |  |  |  |  |  |  |  |
| 1222232030 |  | FTOF- Comp Dsgn of Light Guides (DETCTR) (FY-07) Notebook |  | 125d | 2007-04-09 | 2007-10-03 | 1222232010 | 493d |  | MECH ENG [120 h]; MECH DES [40 h]; SCIENTIST [40 h] | 11,489 |  | ELOUADRHIRI L | 1 | 1 |  | 1.2.2.2.2 | LATIFA E | 07-027 |  |  |  |  |  |  |  |  |  |  |  |  |  |
| 1222223030M |  | EC-FY07 technical design report and safety assessment (FCAL) | milestone | 0d | 2007-04-20 | 2007-04-20 | 1222223030, 1222223020, 1222223025 | 419d | 359d |  |  | 2007-07-24 | ELOUADRHIRI L | 1 | 1 | 07-002 | 1.2.2.2.2 | LATIFA E |  | 5 |  |  |  |  |  |  |  |  |  |  |  |  |
| 1222211010 |  | SVT-Design support structure (SILICON DTCTR) |  | 137d | 2007-05-14 | 2007-11-27 | 1222211005 | 228d | 0d | MECH DES [337.54 h]; MECH ENG [153.43 h] | 23,600.69 | 2007-09-28 | ELOUADRHIRI L | 1 | 1 | 07-002 | 1.2.2.2.2 | LATIFA E |  |  |  |  |  |  |  |  |  |  |  |  |  |  |
| 1222241015 |  | Design of the Mounting Frames (HTCC) |  | 74d | 2007-06-15 | 2007-09-28 | 1222241010 | 296d | 0d | SCIENTIST [61.37 h]; MECH DES [337.54 h] | 17,757.56 | 2007-09-28 | ELOUADRHIRI L | 1 | 1 | 07-002 | 1.2.2.2.2 | LATIFA E | 07-027 |  |  |  |  |  |  |  |  |  |  |  |  |  |
| 1222231020M |  | CTOF-FY07 Techncl Dsgn Report & Sfty Assessmnt (DETCTR) | milestone | 0d | 2007-06-21 | 2007-06-21 | 1222231005, 1222231015, 1222231010 | 325d | 0d |  |  | 2007-09-28 | ELOUADRHIRI L | 1 | 1 | 07-002 | 1.2.2.2.2 | LATIFA E |  | 6 |  |  |  |  |  |  |  |  |  |  |  |  |
| 12222045 |  | CTOF- Compltn of Light Guides Dsgn (DETCTR) |  | 120d | 2007-06-22 | 2007-12-12 | 1222231020M | 445d |  | ELEC DES [200 h]; MECH DES [40 h]; SCIENTIST [40 h]; MECH ENG [120 h] | 20,198.94 |  | ELOUADRHIRI L | 1 | 1 |  | 1.2.2.2.2 | LATIFA E | 07-027 |  |  |  |  |  |  |  |  |  |  |  |  |  |
| 12222050 |  | CTOF- Compltn of Dsgn LG bending (DETCTR) |  | 120d | 2007-06-22 | 2007-12-12 | 1222231020M | 325d | 196d | MECH DES [40 h]; SCIENTIST [40 h]; MECH ENG [120 h] | 11,428.8 |  | ELOUADRHIRI L | 1 | 1 |  | 1.2.2.2.2 | LATIFA E | 07-027 |  |  |  |  |  |  |  |  |  |  |  |  |  |
| 1222242015M |  | LTCC- FY07 Techncl Dsgn Report & Sfty Assessmnt (DETCTR) | milestone | 0d | 2007-08-23 | 2007-08-23 | 1222242010 | 411d | 0d |  |  | 2007-09-28 | ELOUADRHIRI L | 1 | 1 | 07-002 | 1.2.2.2.2 | LATIFA E |  | 6 |  |  |  |  |  |  |  |  |  |  |  |  |
| 12222080 |  | LTCC- Dsgn Extended Working Volume (DETCTR) |  | 110d | 2007-08-24 | 2008-02-08 | 1222242015M | 411d |  | MECH ENG [120 h]; MECH DES [100 h]; SCIENTIST [32 h] | 13,565.6 |  | ELOUADRHIRI L | 1 | 1 |  | 1.2.2.2.2 | LATIFA E | 07-027 |  |  |  |  |  |  |  |  |  |  |  |  |  |
| 1222213025M |  | FDC- FY07 Techncl Dsgn Report & Sfty Assessmnt (DETCTR) | milestone | 0d | 2007-09-28 | 2007-09-28 | 1222213020, 1222213015 | 251d | 0d |  |  | 2007-09-28 | ELOUADRHIRI L | 1 | 1 | 07-002 | 1.2.2.2.2 | LATIFA E |  | 6 |  |  |  |  |  |  |  |  |  |  |  |  |
| 1222232020M |  | FTOF- FY07 technical design report and safety assessment | milestone | 0d | 2007-09-28 | 2007-09-28 | 1222232010, 1222232015, 1222232020, 1222232005 | 371d | 0d |  |  | 2007-09-28 | ELOUADRHIRI L | 1 | 1 | 07-002 | 1.2.2.2.2 | LATIFA E |  | 5 |  |  |  |  |  |  |  |  |  |  |  |  |
| 1222241025M |  | FY07 technical design report and safety assessment (HTCC) | milestone | 0d | 2007-09-28 | 2007-09-28 | 1222241015, 1222241005 | 296d | 247d |  |  | 2007-09-28 | ELOUADRHIRI L | 1 | 1 | 07-002 | 1.2.2.2.2 | LATIFA E | 07-027 | 5 |  |  |  |  |  |  |  |  |  |  |  |  |
| 12222020M |  | FDC- Resource Loaded Schedule for Fab (DETCTR) | milestone | 0d | 2007-10-01 | 2007-10-01 | 1222213025M | 251d | 0d |  |  |  | ELOUADRHIRI L | 1 | 1 |  | 1.2.2.2.2 | LATIFA E |  | 6 |  |  |  |  |  |  |  |  |  |  |  |  |
| 12222025 |  | FDC- Comp Dsgn of Chamb & Stringing Fixture (DETCTR) |  | 245d | 2007-10-01 | 2008-09-25 | 12222020M | 251d | 2d | MECH ENG [240 h]; MECH TECH [640 h]; MECH DES [640 h]; SCIENTIST [40 h]; CONTRB UNIV LBR [1920 h] | 69,607.6 |  | ELOUADRHIRI L | 1 | 1 |  | 1.2.2.2.2 | LATIFA E |  |  |  |  |  |  |  |  |  |  |  |  |  |  |
| 12222030 |  | FDC- Comp Dsgn of Chambers Electrnc's (DETCTR) |  | 245d | 2007-10-01 | 2008-09-25 | 12222020M | 251d | 2d | ELEC TECH [600 h]; SCIENTIST [80 h]; CONTRB UNIV LBR [1920 h]; ELEC DES [1200 h]; ELEC ENG [400 h] | 106,695.6 |  | ELOUADRHIRI L | 1 | 1 |  | 1.2.2.2.2 | LATIFA E |  |  |  |  |  |  |  |  |  |  |  |  |  |  |
| 12222060 |  | FTOF- Comp Dsgn of Backing Struct for Scintillators (DETCTR) + |  | 125d | 2007-10-01 | 2008-04-07 | 1222232020M, 1222232005 | 371d |  | MECH DES [40 h]; SCIENTIST [40 h]; MECH ENG [120 h] | 11,610.8 |  | ELOUADRHIRI L | 1 | 1 |  | 1.2.2.2.2 | LATIFA E | 07-027 |  |  |  |  |  |  |  |  |  |  |  |  |  |
| 12222065 |  | FTOF- Comp Magnetic Shielding Dsgn (DETCTR) + |  | 125d | 2007-10-01 | 2008-04-07 | 1222232020M, 1222232015 | 371d |  | MECH ENG [120 h]; SCIENTIST [40 h]; MECH DES [80 h] | 13,310 |  | ELOUADRHIRI L | 1 | 1 |  | 1.2.2.2.2 | LATIFA E | 07-027 |  |  |  |  |  |  |  |  |  |  |  |  |  |
| 12222070 |  | FTOF- Comp PMT Housing & Grounding Dsgn (DETCTR) + |  | 125d | 2007-10-01 | 2008-04-07 | 1222232020M, 1222232020 | 371d |  | ELEC DES [200 h]; MECH ENG [120 h]; MECH DES [40 h]; SCIENTIST [40 h] | 20,520.8 |  | ELOUADRHIRI L | 1 | 1 |  | 1.2.2.2.2 | LATIFA E | 07-027 |  |  |  |  |  |  |  |  |  |  |  |  |  |
| 12222005 |  | SVT- Dsgn Supprt Struct Optimztn Comptd (DETCTR) |  | 110d | 2007-11-28 | 2008-05-12 | 1222211020, 9-080M, 1222211010 | 228d | 0d | MECH DES [440 h]; PROCUREMENT<$50K 60 | 21,467.01 |  | ELOUADRHIRI L | 1 | 1 |  | 1.2.2.2.2 | LATIFA E | 07-027 |  |  |  |  |  |  |  |  |  |  |  |  |  |
| 12222010 |  | SVT- Dsgn of VME Board Comptd (DETCTR) |  | 125d | 2008-03-31 | 2008-09-24 | 12222005 FS-31d | 252d | 24d | ELEC ENG [880 h]; ELEC DES [880 h] | 93,975.2 |  | ELOUADRHIRI L | 1 | 1 |  | 1.2.2.2.2 | LATIFA E | 07-027 |  |  |  |  |  |  |  |  |  |  |  |  |  |
| 12222015 |  | FY08 SVT- Dsgn Readout Software Comptd (DETCTR) |  | 129d | 2008-03-31 | 2008-09-30 | 12222005 FS-31d | 228d | 0d | COMP SCIENT [190.47 h]; SCIENTIST [10.39 h]; ELEC ENG [761.88 h]; CONTRB UNIV LBR [761.88 h]; ELEC TECH [380.94 h]; OFFICE [17.32 h] | 74,355.01 |  | ELOUADRHIRI L | 1 | 1 |  | 1.2.2.2.2 | LATIFA E |  |  | EXP0809 |  |  |  |  |  |  |  |  |  |  |  |
| 12222000 |  | FY08 SVT- Comp Dsgn Layout (DETCTR)+ |  | 98d | 2008-05-13 | 2008-09-30 | 1132897 | 236d | 0d | MECH DES [392 h] | 16,652.16 |  | ELOUADRHIRI L | 1 | 1 |  | 1.2.2.2.2 | LATIFA E | 07-027 |  | EXP0809 | FY08-09 |  |  |  |  |  |  |  |  |  |  |
| 12222035M |  | FDC-Compltn of PED (DETCTR)+ | milestone | 0d | 2008-09-29 | 2008-09-29 | 1132865M, 12222025, 12222030 | 249d | 1d |  |  |  | ELOUADRHIRI L | 1 | 1 |  | 1.2.2.2.2 | LATIFA E | 07-027 | 6 |  |  |  |  |  |  |  |  |  |  |  |  |
| 12222040 |  | FY08 Exp EC- Comp Dsgn of Assy (DETCTR) |  | 1d | 2008-09-30 | 2008-09-30 | 1132851M, 1222223030M | 60d | 0d | MECH DES [2.4 h]; SCIENTIST [0.27 h]; MECH ENG [0.93 h] | 176.27 |  | ELOUADRHIRI L | 1 | 1 |  | 1.2.2.2.2 | LATIFA E |  |  | EXP0809 | FY08-09 |  |  |  |  |  |  |  |  |  |  |
| 12222055 |  | PROC CTOF- Comp Dsgn Supprt for Triplet with 1 m long bend LG's (DETCTR)+ |  | 120d | 2008-09-30 | 2009-03-30 | 1132890M, 12222050 | 129d |  | PROCUREMENT<$50K 60 NO ESCALATION FY09 | 2,765.49 |  | ELOUADRHIRI L | 1 | 1 |  | 1.2.2.2.2 | LATIFA E | 07-027 |  | EXP0809 | FY08-09 | 08-016 | 09-012 |  |  |  |  |  |  |  |  |
| 12222055a |  | FY08 Exp CTOF- Comp Dsgn Supprt for Triplet with 1 m long bend LG's (DETCTR)+ |  | 1d | 2008-09-30 | 2008-09-30 | 1132890M, 12222050 | 129d | 0d | MECH ENG [1 h]; SCIENTIST [0.33 h]; MECH DES [1 h] | 124.87 |  | ELOUADRHIRI L | 1 | 1 |  | 1.2.2.2.2 | LATIFA E | 07-027 |  | EXP0809 | FY08-09 | 08-016 | 09-012 |  |  |  |  |  |  |  |  |
| 12222075 |  | PROC HTCC- Dsgn of Whole Module (DETCTR) |  | 200d | 2008-09-30 | 2009-07-22 | 1222241025M, 1132831M | 49d | 0d | PROCUREMENT<$50K 60 NO ESCALATION FY09 | 2,765.49 |  | ELOUADRHIRI L | 1 | 1 |  | 1.2.2.2.2 | LATIFA E |  |  | EXP0809 | FY08-09 | 08-016 | 09-012 |  |  |  |  |  |  |  |  |
| 12222075a |  | FY08 Exp HTCC- Dsgn of Whole Module (DETCTR) |  | 1d | 2008-09-30 | 2008-09-30 | 1132831M, 1222241025M | 49d | 0d | ELEC DES [2.2 h]; SCIENTIST [0.4 h]; MECH DES [2.2 h]; MECH ENG [0.8 h] | 265.85 |  | ELOUADRHIRI L | 1 | 1 |  | 1.2.2.2.2 | LATIFA E |  |  | EXP0809 | FY08-09 | 08-016 | 09-012 |  |  |  |  |  |  |  |  |
| 12222000a |  | FY09 SVT- Comp Dsgn Layout (DETCTR)+ |  | 12d | 2008-10-01 | 2008-10-16 | 12222000 | 236d |  | MECH DES [48 h] | 2,104.32 |  | ELOUADRHIRI L | 1 | 1 |  | 1.2.2.2.2 | LATIFA E | 07-027 |  | EXP0809 | FY08-09 |  |  |  |  |  |  |  |  |  |  |
| 12222015a |  | FY09 SVT- Dsgn Readout Software Comptd (DETCTR) |  | 20d | 2008-10-01 | 2008-10-28 | 12222015 | 228d | 0d | OFFICE [2.68 h]; COMP SCIENT [29.53 h]; ELEC ENG [118.12 h]; SCIENTIST [1.61 h]; CONTRB UNIV LBR [118.12 h]; ELEC TECH [59.06 h] | 11,895.62 |  | ELOUADRHIRI L | 1 | 1 |  | 1.2.2.2.2 | LATIFA E |  |  | EXP0809 |  |  |  |  |  |  |  |  |  |  |  |
| 12222040a |  | FY09 Exp EC- Comp Dsgn of Assy (DETCTR) |  | 149d | 2008-10-01 | 2009-05-11 | 12222040 | 60d | 0d | MECH ENG [139.07 h]; MECH DES [357.6 h]; SCIENTIST [39.73 h] | 27,104.29 |  | ELOUADRHIRI L | 1 | 1 |  | 1.2.2.2.2 | LATIFA E |  |  | EXP0809 | FY08-09 |  |  |  |  |  |  |  |  |  |  |
| 12222055b |  | FY09 Exp CTOF- Comp Dsgn Supprt for Triplet with 1 m long bend LG's (DETCTR)+ |  | 119d | 2008-10-01 | 2009-03-30 | 12222055a | 129d |  | MECH DES [119 h]; SCIENTIST [39.67 h]; MECH ENG [119 h] | 15,359.54 |  | ELOUADRHIRI L | 1 | 1 |  | 1.2.2.2.2 | LATIFA E | 07-027 |  | EXP0809 | FY08-09 | 08-016 | 09-012 |  |  |  |  |  |  |  |  |
| 12222075b |  | FY09 Exp HTCC- Dsgn of Whole Module (DETCTR) |  | 199d | 2008-10-01 | 2009-07-22 | 12222075a | 49d | 0d | MECH ENG [159.2 h]; ELEC DES [437.8 h]; SCIENTIST [79.6 h]; MECH DES [437.8 h] | 54,596.84 |  | ELOUADRHIRI L | 1 | 1 |  | 1.2.2.2.2 | LATIFA E |  |  | EXP0809 | FY08-09 | 08-016 | 09-012 |  |  |  |  |  |  |  |  |
| 142213009EX |  | FY09 Travel (FWD Chambers) |  | 59d | 2008-10-01 | 2008-12-24 | 9-090M | 248d | 0d | TRAVEL | 633.31 |  | ELOUADRHIRI L | 1 | 1 |  |  | LATIFA E |  |  |  |  |  |  | 07-024 | 08-058 | 10-015 | 11-026 | 11 -035 | 13-002F |  |  |
| 12222015M |  | SVT- Techncl Dsgn Report & drawings (DETCTR)+ | milestone | 0d | 2008-10-28 | 2008-10-28 | 12222015a, 12222010, 1132800M | 228d |  |  |  |  | ELOUADRHIRI L | 1 | 1 |  | 1.2.2.2.2 | LATIFA E | 07-027 | 6 |  |  |  |  |  |  |  |  |  |  |  |  |
| 1222223040 |  | EC- Dsgn of Lifting & Mounting Hardware (DETCTR)+ |  | 110d | 2009-01-30 | 2009-07-07 | 12222040a FS-71d | 60d |  | SCIENTIST [52 h]; MECH DES [320 h]; MECH ENG [200 h] | 30,132.32 |  | ELOUADRHIRI L | 1 | 1 |  | 1.2.2.2.2 | LATIFA E | 07-027 |  |  |  |  |  |  |  |  |  |  |  |  |  |
| 1222223041M |  | EC- Final Techncl Dsgn Report & Sfty Assessmnt (DETCTR)+ | milestone | 0d | 2009-05-11 | 2009-05-11 | 12222040a | 99d |  |  |  |  | ELOUADRHIRI L | 1 | 1 |  | 1.2.2.2.2 | LATIFA E |  | 6 |  |  |  |  |  |  |  |  |  |  |  |  |
| 1222241035M |  | HTCC- Techncl Dsgn Report (DETCTR)+ | milestone | 0d | 2009-07-22 | 2009-07-22 | 12222075, 12222075b | 49d | 0d |  |  |  | ELOUADRHIRI L | 1 | 1 |  | 1.2.2.2.2 | LATIFA E |  | 6 |  |  |  |  |  |  |  |  |  |  |  |  |
| 1222242020 |  | Re-Baseline Actuals Adjustment |  | 1d | 2013-08-30 | 2013-08-30 | 9-130M FS+227d | 20d |  | PROCUREMENT>$50K 69 NO ESCALATION | 504,259.51 |  | ELOUADRHIRI L | 1 | 1 |  |  | LATIFA E |  |  |  |  |  |  |  |  |  |  |  |  | 13-014 | ADJ |

Notes:
- 1222232030: Corrective Actions: Latifa Plans To Start In April 2007. PMC

| ID | WBS | Activity | Type | Duration | Start | Finish | Predecessors | Total float | Free float | Resources | Cost | Planned FinishUDF | RESP - Responsibility | STRT%COMP for CM EVM | FNSH%COMP for CM EVM | CR 07-002 | WBS ASSIGNMENT | CAM RESPONSIBLE | Milestone Level | CR 07-027 | CR 13-014 | ReBaseline Actuals Adjustment |
| --- | --- | --- | --- | --- | --- | --- | --- | --- | --- | --- | --- | --- | --- | --- | --- | --- | --- | --- | --- | --- | --- | --- |
|  | 1 | **1.2.2.2.2.1 TRACKING** |  |  |  |  |  |  |  |  |  |  |  |  |  |  |  |  |  |  |  |  |
|  | 1 | **1.2.2.2.2.1.1 SILICON DETECTOR** |  |  |  |  |  |  |  |  |  |  |  |  |  |  |  |  |  |  |  |  |
|  | 2 | **1.2.2.2.2.1.2 CENTRAL TRACKER** |  |  |  |  |  |  |  |  |  |  |  |  |  |  |  |  |  |  |  |  |
|  | 3 | **1.2.2.2.2.1.3 FORWARD DRIFT CHAMBERS** |  |  |  |  |  |  |  |  |  |  |  |  |  |  |  |  |  |  |  |  |
|  | 2 | **1.2.2.2.2.2 CALORIMETRY** |  |  |  |  |  |  |  |  |  |  |  |  |  |  |  |  |  |  |  |  |
|  | 1 | **1.2.2.2.2.2.1 CENTRAL CALORIMETER** |  |  |  |  |  |  |  |  |  |  |  |  |  |  |  |  |  |  |  |  |
|  | 2 | **1.2.2.2.2.2.2 COIL CALORIMETER** |  |  |  |  |  |  |  |  |  |  |  |  |  |  |  |  |  |  |  |  |
|  | 3 | **1.2.2.2.2.2.3 FORWARD CALORIMETER** |  |  |  |  |  |  |  |  |  |  |  |  |  |  |  |  |  |  |  |  |
|  | 3 | **1.2.2.2.2.3 TIME OF FLIGHT** |  |  |  |  |  |  |  |  |  |  |  |  |  |  |  |  |  |  |  |  |
|  | 1 | **1.2.2.2.2.3.1 CENTRAL TOF** |  |  |  |  |  |  |  |  |  |  |  |  |  |  |  |  |  |  |  |  |
|  | 2 | **1.2.2.2.2.3.2 FORWARD TOF** |  |  |  |  |  |  |  |  |  |  |  |  |  |  |  |  |  |  |  |  |
|  | 4 | **1.2.2.2.2.4 CERENKOV** |  |  |  |  |  |  |  |  |  |  |  |  |  |  |  |  |  |  |  |  |
|  | 1 | **1.2.2.2.2.4.1 HIGH THRESHOLD CC** |  |  |  |  |  |  |  |  |  |  |  |  |  |  |  |  |  |  |  |  |
|  | 2 | **1.2.2.2.2.4.2 LOW THRESHOLD CC** |  |  |  |  |  |  |  |  |  |  |  |  |  |  |  |  |  |  |  |  |
|  | 3 | **1.2.2.2.3 COMPUTING** |  |  | 2006-10-02 | 2013-08-30 |  |  |  |  |  |  |  |  |  |  |  |  |  |  |  |  |
| 122231005 |  | Trigger- Level 1 design (TRGR SYS) |  | 110d | 2006-10-02 | 2007-03-16 | 9-070M | 387d | 71d | SCIENTIST [337.8 h] | 21,683.38 | 2007-03-16 | ELOUADRHIRI L | 1 | 1 | 07-002 | 1.2.2.2.3 | LATIFA E |  |  |  |  |
| 122231010 |  | Trigger- Level 2 design (TRGR SYS) |  | 125d | 2006-12-21 | 2007-06-26 | 9-070M FS+56d | 316d | 0d | SCIENTIST [675.07 h] | 43,118.61 | 2007-06-26 | ELOUADRHIRI L | 1 | 1 | 07-002 | 1.2.2.2.3 | LATIFA E |  |  |  |  |
| 122231015 |  | Trigger- Electronic design (TRGR SYS) |  | 66d | 2007-06-27 | 2007-09-28 | 122231010, 122231005 | 316d | 0d | ELEC ENG [337.54 h]; SCIENTIST [158.84 h] | 29,994.62 | 2007-09-28 | ELOUADRHIRI L | 1 | 1 | 07-002 | 1.2.2.2.3 | LATIFA E |  |  |  |  |
| 122231020M |  | Trigger- Design Report (TRGR SYS) | milestone | 0d | 2007-09-28 | 2007-09-28 | 122231015 | 316d | 0d |  |  | 2007-09-28 | ELOUADRHIRI L | 1 | 1 | 07-002 | 1.2.2.2.3 | LATIFA E | 5 |  |  |  |
| 12223025 |  | Trigger- Compltn of L-1 Dsgn Scheme (COMPUTNG) |  | 60d | 2007-10-01 | 2008-01-03 | 122231020M, 122231015 | 316d | 0d | ELEC ENG [40 h]; SCIENTIST [84 h]; PROCUREMENT<$50K 60 | 10,485.77 |  | ELOUADRHIRI L | 1 | 1 |  | 1.2.2.2.3 | LATIFA E |  | 07-027 |  |  |
| 12223030 |  | Trigger- Compltn of L-2 Dsgn Scheme (COMPUTNG) |  | 60d | 2008-01-04 | 2008-03-31 | 12223025 | 316d | 0d | SCIENTIST [60 h]; ELEC ENG [80 h] | 8,715.4 |  | ELOUADRHIRI L | 1 | 1 |  | 1.2.2.2.3 | LATIFA E |  |  |  |  |
| 12223035 |  | Trigger- Compltn of Electronic Dsgn (COMPUTNG) |  | 60d | 2008-04-01 | 2008-06-24 | 12223030 | 316d | 0d | ELEC ENG [100 h] | 6,224 |  | ELOUADRHIRI L | 1 | 1 |  | 1.2.2.2.3 | LATIFA E |  | 07-027 |  |  |
| 12223040M |  | CLAS12 Trigger Techncl Dsgn Report (COMPUTNG)+ | milestone | 0d | 2008-06-24 | 2008-06-24 | 12223035 | 316d |  |  |  |  | ELOUADRHIRI L | 1 | 1 |  | 1.2.2.2.3 | LATIFA E | 6 | 07-027 |  |  |
| 12223045 |  | CLAS12 Slow Control Dsgn Sys (COMPUTNG)++ |  | 110d | 2009-04-01 | 2009-09-03 | 9-090M FS+120d | 18d |  | SCIENTIST [400 h]; PD UNIV STUDNT [440 h] | 29,976.4 |  | ELOUADRHIRI L | 1 | 1 |  | 1.2.2.2.3 | LATIFA E |  | 07-027 |  |  |
| 122231025 |  | Re-Baseline Actuals Adjustment |  | 1d | 2013-08-30 | 2013-08-30 | 9-130M FS+227d | 20d |  | PROCUREMENT>$50K 69 NO ESCALATION | -68,118.29 |  | ELOUADRHIRI L | 1 | 1 |  |  | LATIFA E |  |  | 13-014 | ADJ |

| ID | WBS | Activity | Type | Duration | Start | Finish | Predecessors | Total float | Free float | Resources | Cost | RESP - Responsibility | STRT%COMP for CM EVM | FNSH%COMP for CM EVM | CR 07-027 | Profile change | WBS ASSIGNMENT | CAM RESPONSIBLE | CR 13-014 | ReBaseline Actuals Adjustment | Planned FinishUDF | CR 07-002 | Milestone Level |
| --- | --- | --- | --- | --- | --- | --- | --- | --- | --- | --- | --- | --- | --- | --- | --- | --- | --- | --- | --- | --- | --- | --- | --- |
|  | 1 | **1.2.2.2.3.1 TRIGGER SYSTEM (Scintillators)** |  |  |  |  |  |  |  |  |  |  |  |  |  |  |  |  |  |  |  |  |  |
|  | 2 | **1.2.2.2.3.2 DAQ** |  |  |  |  |  |  |  |  |  |  |  |  |  |  |  |  |  |  |  |  |  |
|  | 3 | **1.2.2.2.3.3 ONLINE COMPUTING** |  |  |  |  |  |  |  |  |  |  |  |  |  |  |  |  |  |  |  |  |  |
|  | 4 | **1.2.2.2.3.4 OFFLINE COMPUTING** |  |  |  |  |  |  |  |  |  |  |  |  |  |  |  |  |  |  |  |  |  |
|  | 5 | **1.2.2.2.3.5 SLOW CONTROLS** |  |  |  |  |  |  |  |  |  |  |  |  |  |  |  |  |  |  |  |  |  |
|  | 4 | **1.2.2.2.4 ELECTRONICS** |  |  | 2008-01-04 | 2013-08-30 |  |  |  |  |  |  |  |  |  |  |  |  |  |  |  |  |  |
| 12224005 |  | FADC Analysis (ADC) (ELECTRNC'S)++ |  | 120d | 2008-01-04 | 2008-06-24 | 9-080M FS+60d | 26d |  | PROCUREMENT<$50K 60; SCIENTIST [252 h] | 18,457.53 | ELOUADRHIRI L | 1 | 1 | 07-027 | C | 1.2.2.2.4 | LATIFA E |  |  |  |  |  |
| 12224010 |  | Re-Baseline Actuals Adjustment |  | 1d | 2013-08-30 | 2013-08-30 | 9-130M FS+227d | 20d |  | PROCUREMENT>$50K 69 NO ESCALATION | -18,458.17 | ELOUADRHIRI L | 1 | 1 |  |  |  | LATIFA E | 13-014 | ADJ |  |  |  |
|  | 1 | **1.2.2.2.4.1 ADC** |  |  |  |  |  |  |  |  |  |  |  |  |  |  |  |  |  |  |  |  |  |
|  | 2 | **1.2.2.2.4.2 TDC** |  |  |  |  |  |  |  |  |  |  |  |  |  |  |  |  |  |  |  |  |  |
|  | 3 | **1.2.2.2.4.3 SCALERS** |  |  |  |  |  |  |  |  |  |  |  |  |  |  |  |  |  |  |  |  |  |
|  | 4 | **1.2.2.2.4.4 HIGH VOLTAGE** |  |  |  |  |  |  |  |  |  |  |  |  |  |  |  |  |  |  |  |  |  |
|  | 5 | **1.2.2.2.4.5 PRE-TRIGGER** |  |  |  |  |  |  |  |  |  |  |  |  |  |  |  |  |  |  |  |  |  |
|  | 6 | **1.2.2.2.4.6 LOGIC** |  |  |  |  |  |  |  |  |  |  |  |  |  |  |  |  |  |  |  |  |  |
|  | 7 | **1.2.2.2.4.7 CRATES, RACKS** |  |  |  |  |  |  |  |  |  |  |  |  |  |  |  |  |  |  |  |  |  |
|  | 5 | **1.2.2.2.5 BEAMLINE** |  |  | 2006-10-02 | 2013-08-30 |  |  |  |  |  |  |  |  |  |  |  |  |  |  |  |  |  |
| 122254005 |  | BL-Shielding design for central detector (BL COMPON) |  | 110d | 2006-10-02 | 2007-03-16 | 9-070M | 251d | 0d | VISTNG USERS [398.9 h] | 6,865.16 | ELOUADRHIRI L | 1 | 1 |  |  | 1.2.2.2.5 | LATIFA E |  |  | 2007-03-16 | 07-002 |  |
| 122253000 |  | Target- Design of Longitudinal polarized target (TARGETS) |  | 150d | 2007-01-04 | 2007-08-07 | 9-070M FS+60d | 288d | 0d | MECH DES [521.64 h]; MECH ENG [456.67 h] | 50,818.7 | ELOUADRHIRI L | 1 | 1 |  |  | 1.2.2.2.5 | LATIFA E |  |  | 2007-08-07 | 07-002 |  |
| 122254010 |  | BL-Forward detector shielding (BL COMPON) |  | 137d | 2007-03-19 | 2007-09-28 | 122254005 | 251d | 0d | MECH DES [122.74 h]; MECH ENG [30.8 h]; VISTNG USERS [398.9 h] | 13,846.86 | ELOUADRHIRI L | 1 | 1 |  |  | 1.2.2.2.5 | LATIFA E |  |  | 2007-09-28 | 07-002 |  |
| 122253005M |  | Target- Design Report (TARGETS) | milestone | 0d | 2007-08-07 | 2007-08-07 | 122253000 | 288d | 37d |  |  | ELOUADRHIRI L | 1 | 1 |  |  | 1.2.2.2.5 | LATIFA E |  |  | 2007-08-07 | 07-002 | 5 |
| 122254015M |  | BL-Design Report (BL COMPON) | milestone | 0d | 2007-09-28 | 2007-09-28 | 122254010, 122253005M | 251d |  |  |  | ELOUADRHIRI L | 1 | 1 |  |  | 1.2.2.2.5 | LATIFA E |  |  | 2007-09-28 | 07-002 | 5 |
| 12225045 |  | BL COMPON- Beam Vac Sys (BL) |  | 60d | 2008-01-04 | 2008-03-31 | 9-080M FS+60d | 86d | 63d | MECH DES [80 h]; SCIENTIST [4 h]; MECH ENG [40 h] | 6,121.08 | ELOUADRHIRI L | 1 | 1 | 07-027 | C | 1.2.2.2.5 | LATIFA E |  |  |  |  |  |
| 12225050 |  | BL COMPON- Dsgn of BL Shielding (BL)+ |  | 60d | 2008-06-30 | 2008-09-23 | 12225045, 1135025 | 253d |  | MECH DES [80 h]; SCIENTIST [80 h]; MECH ENG [40 h] | 10,853.6 | ELOUADRHIRI L | 1 | 1 | 07-027 |  | 1.2.2.2.5 | LATIFA E |  |  |  |  |  |
| 12225015 |  | Moller Polarimter Optic Dsgn (BL) |  | 40d | 2008-10-01 | 2008-11-25 | 9-090M | 168d | 0d | MECH ENG [120 h]; MECH DES [40 h]; CONTRB UNIV LBR [40 h] | 9,410.8 | ELOUADRHIRI L | 1 | 1 | 07-027 |  | 1.2.2.2.5 | LATIFA E |  |  |  |  |  |
| 12225025 |  | Target- Layout (BL) |  | 55d | 2008-10-06 | 2008-12-23 | 9-090M FS+3d, 122254015M | 0d |  | MECH DES [160 h]; SCIENTIST [40 h]; CONTRB UNIV LBR [120 h]; MECH ENG [80 h] | 14,689.6 | ELOUADRHIRI L | 1 | 1 | 07-027 |  | 1.2.2.2.5 | LATIFA E |  |  |  |  |  |
| 12225020 |  | Moller Polarimter Mech Supprt (BL)+ |  | 40d | 2008-11-26 | 2009-02-02 | 12225015 | 168d |  | MECH ENG [120 h]; MECH DES [40 h]; SCIENTIST [24 h]; CONTRB UNIV LBR [40 h] | 10,953.04 | ELOUADRHIRI L | 1 | 1 | 07-027 |  | 1.2.2.2.5 | LATIFA E |  |  |  |  |  |
| 12225030 |  | Target- Vac Sys Dsgn & Mech Supprt (BL) |  | 95d | 2008-12-24 | 2009-05-15 | 12225025 | 0d |  | MECH DES [220 h]; SCIENTIST [100 h]; CONTRB UNIV LBR [160 h]; MECH ENG [120 h] | 23,728 | ELOUADRHIRI L | 1 | 1 |  |  | 1.2.2.2.5 | LATIFA E |  |  |  |  |  |
| 12225035 |  | Target- Dsgn of Cryogenic Sys (BL) |  | 55d | 2009-05-18 | 2009-08-04 | 12225030 | 0d |  | CONTRB UNIV LBR [80 h]; MECH ENG [80 h]; MECH DES [160 h]; SCIENTIST [40 h] | 14,689.6 | ELOUADRHIRI L | 1 | 1 |  |  | 1.2.2.2.5 | LATIFA E |  |  |  |  |  |
| 12225040 |  | Target- Dsgn Control Sys (BL)+ |  | 40d | 2009-08-05 | 2009-09-30 | 12225035 | 0d |  | CONTRB UNIV LBR [80 h]; SCIENTIST [44 h]; MECH ENG [80 h]; MECH DES [160 h] | 14,946.64 | ELOUADRHIRI L | 1 | 1 | 07-027 |  | 1.2.2.2.5 | LATIFA E |  |  |  |  |  |
| 122254020 |  | Re-Baseline Actuals Adjustment |  | 1d | 2013-08-30 | 2013-08-30 | 9-130M FS+227d | 20d |  | PROCUREMENT>$50K 69 NO ESCALATION | -107,087.41 | ELOUADRHIRI L | 1 | 1 |  |  |  | LATIFA E | 13-014 | ADJ |  |  |  |

| ID | WBS | Activity | Type | Duration | Start | Finish | Predecessors | Total float | Free float | Resources | Cost | RESP - Responsibility | STRT%COMP for CM EVM | FNSH%COMP for CM EVM | CR 07-027 | WBS ASSIGNMENT | CAM RESPONSIBLE | EXPNS ACT BRIDGING FY SPLIT | ACT BRIDGING FY SPLIT | CR 13-014 | ReBaseline Actuals Adjustment | Planned FinishUDF | CR 07-005 | CR 09-012 | Milestone Level | CR 08-058 | CR 12-012 |
| --- | --- | --- | --- | --- | --- | --- | --- | --- | --- | --- | --- | --- | --- | --- | --- | --- | --- | --- | --- | --- | --- | --- | --- | --- | --- | --- | --- |
|  | 1 | **1.2.2.2.5.1 FARADAY CUP UPGRADE** |  |  |  |  |  |  |  |  |  |  |  |  |  |  |  |  |  |  |  |  |  |  |  |  |  |
|  | 2 | **1.2.2.2.5.2 MOLLER POLARIMETER UPGRADE** |  |  |  |  |  |  |  |  |  |  |  |  |  |  |  |  |  |  |  |  |  |  |  |  |  |
|  | 3 | **1.2.2.2.5.3 TARGETS** |  |  |  |  |  |  |  |  |  |  |  |  |  |  |  |  |  |  |  |  |  |  |  |  |  |
|  | 4 | **1.2.2.2.5.4 BEAMLINE COMPONENTS** |  |  |  |  |  |  |  |  |  |  |  |  |  |  |  |  |  |  |  |  |  |  |  |  |  |
|  | 6 | **1.2.2.2.6 INFRASTRUCTURE** |  |  | 2008-04-01 | 2013-08-30 |  |  |  |  |  |  |  |  |  |  |  |  |  |  |  |  |  |  |  |  |  |
| 12226010 |  | FY08 Exp Utilities Dsgn of Connections to Cryogenic systems (Utilities) (INFSTRCTR)+ |  | 128d | 2008-04-01 | 2008-09-30 | 9-080M FS+120d | 116d | 0d | MECH DES [433.23 h]; MECH ENG [236.31 h] | 33,017.02 | ELOUADRHIRI L | 1 | 1 | 07-027 | 1.2.2.2.6 | LATIFA E | EXP0809 |  |  |  |  |  |  |  |  |  |
| 12226015 |  | FY08 Exp Dsgn Mech Supprt Frames for HTCC (INFSTRCTR)+ |  | 128d | 2008-04-01 | 2008-09-30 | 9-080M FS+120d | 56d | 0d | MECH TECH [96 h]; SCIENTIST [32 h]; MECH ENG [352 h]; MECH DES [416 h] | 45,195.2 | ELOUADRHIRI L | 1 | 1 | 07-027 | 1.2.2.2.6 | LATIFA E | EXP0809 | FY08-09 |  |  |  |  |  |  |  |  |
| 12226020 |  | FY08 Exp Dsgn Mech Supprt Frames for Central Detector (INFSTRCTR)+ |  | 128d | 2008-04-01 | 2008-09-30 | 9-080M FS+120d | 56d | 0d | MECH ENG [352 h]; SCIENTIST [32 h]; MECH DES [416 h]; MECH TECH [96 h] | 45,195.2 | ELOUADRHIRI L | 1 | 1 | 07-027 | 1.2.2.2.6 | LATIFA E | EXP0809 | FY08-09 |  |  |  |  |  |  |  |  |
| 12226010a |  | FY09 Exp Utilities Dsgn of Connections to Cryogenic systems (Utilities) (INFSTRCTR)+ |  | 132d | 2008-10-01 | 2009-04-16 | 12226010 | 116d |  | MECH ENG [243.69 h]; MECH DES [446.77 h] | 35,136.26 | ELOUADRHIRI L | 1 | 1 | 07-027 | 1.2.2.2.6 | LATIFA E | EXP0809 |  |  |  |  |  |  |  |  |  |
| 12226015a |  | FY09 Exp Dsgn Mech Supprt Frames for HTCC (INFSTRCTR)+ |  | 192d | 2008-10-01 | 2009-07-13 | 12226015 | 56d |  | SCIENTIST [48 h]; MECH ENG [528 h]; MECH DES [624 h]; MECH TECH [144 h] | 69,957.12 | ELOUADRHIRI L | 1 | 1 | 07-027 | 1.2.2.2.6 | LATIFA E | EXP0809 | FY08-09 |  |  |  |  |  |  |  |  |
| 12226020a |  | FY09 Exp Dsgn Mech Supprt Frames for Central Detector (INFSTRCTR)+ |  | 192d | 2008-10-01 | 2009-07-13 | 12226020 | 56d |  | MECH DES [624 h]; MECH TECH [144 h]; SCIENTIST [48 h]; MECH ENG [528 h] | 69,957.12 | ELOUADRHIRI L | 1 | 1 | 07-027 | 1.2.2.2.6 | LATIFA E | EXP0809 | FY08-09 |  |  |  |  |  |  |  |  |
| 12226025 |  | Re-Baseline Actuals Adjustment |  | 1d | 2013-08-30 | 2013-08-30 | 9-130M FS+227d | 20d |  | PROCUREMENT>$50K 69 NO ESCALATION | -30,146.03 | ELOUADRHIRI L | 1 | 1 |  |  | LATIFA E |  |  | 13-014 | ADJ |  |  |  |  |  |  |
|  | 1 | **1.2.2.2.6.1 UTILITIES** |  |  |  |  |  |  |  |  |  |  |  |  |  |  |  |  |  |  |  |  |  |  |  |  |  |
|  | 2 | **1.2.2.2.6.2 MECHANICAL FRAMES** |  |  |  |  |  |  |  |  |  |  |  |  |  |  |  |  |  |  |  |  |  |  |  |  |  |
|  | 3 | **1.2.2.2.6.3 ASSEMBLY** |  |  |  |  |  |  |  |  |  |  |  |  |  |  |  |  |  |  |  |  |  |  |  |  |  |
|  | 4 | **1.2.2.2.6.4 INSTALLATION** |  |  |  |  |  |  |  |  |  |  |  |  |  |  |  |  |  |  |  |  |  |  |  |  |  |
|  | 3 | **1.2.2.3 HALL C** |  |  | 2006-10-02 | 2013-08-30 |  |  |  |  |  |  |  |  |  |  |  |  |  |  |  |  |  |  |  |  |  |
|  | 1 | **1.2.2.3.1 MAGNET** |  |  | 2006-10-02 | 2013-08-30 |  |  |  |  |  |  |  |  |  |  |  |  |  |  |  |  |  |  |  |  |  |
|  | 1 | **1.2.2.3.1.1 Q-1 QUADRUPOLE** |  |  | 2006-10-02 | 2013-08-30 |  |  |  |  |  |  |  |  |  |  |  |  |  |  |  |  |  |  |  |  |  |
| 122311007LOE |  | FY07 Overview entire PED project Q1-QUAD |  | 247d | 2006-10-02 | 2007-09-28 | 9-070M | 0d |  |  |  | FENKER H | 1 | 1 |  | 1.2.2.3.1.1 | HOWARD F |  |  |  |  | 2007-09-28 | 07-005 | 09-012 |  |  |  |
| 122311010 |  | Perform magnetic analysis and analyze tolerances Q1-QUAD |  | 130d | 2006-10-02 | 2007-04-13 | 9-070M | 68d | 51d | SCIENTIST [140 h]; MECH ENG [240.8 h] | 23,856.59 | FENKER H | 1 | 1 |  | 1.2.2.3.1.1 | HOWARD F |  |  |  |  | 2007-04-13 | 07-005 |  |  |  |  |
| 122311020 |  | Design LN2 shield Q1-QUAD |  | 60d | 2006-10-02 | 2007-01-03 | 9-070M | 17d | 0d | MECH ENG [40 h]; MECH DES [280 h] | 14,882.8 | FENKER H | 1 | 1 |  | 1.2.2.3.1.1 | HOWARD F |  |  |  |  | 2007-01-03 | 07-005 |  |  |  |  |
| 122311030 |  | Design control system Q1-QUAD |  | 40d | 2006-10-02 | 2006-11-28 | 9-070M | 78d | 61d | PROCUREMENT<$50K 60 | 31,990 | FENKER H | 1 | 1 |  | 1.2.2.3.1.1 | HOWARD F |  |  |  |  | 2006-11-28 | 07-005 |  |  |  |  |
| 122311035 |  | Trial Winding of Q1 Coil Q1-QUAD |  | 109d | 2007-01-04 | 2007-06-08 | 122311020 | 17d | 0d | PROCUREMENT<$50K 60 | 35,000 | FENKER H | 1 | 1 | 07-027 | 1.2.2.3.1.1 | HOWARD F |  |  |  |  | 2007-08-06 | 07-005 |  |  |  |  |
| 122311045 |  | P-1 Prepare reference design Q1-QUAD |  | 187d | 2007-03-06 | 2007-11-28 | 122311020, 122311035 FS-68d, 122311030, 122311010 FS-80d | 17d | 0d | SCIENTIST [476 h]; MECH ENG [193.6 h]; MECH DES [96.8 h] | 45,619.88 | FENKER H | 1 | 1 | 07-027 | 1.2.2.3.1.1 | HOWARD F |  |  |  |  | 2007-09-28 | 07-005 |  |  |  |  |
| 122311047 |  | Dsgn Vac Vessel Q1-QUAD |  | 65d | 2007-10-01 | 2008-01-10 | 9-080M | 60d | 0d | MECH DES [240 h] | 10,195.2 | FENKER H | 1 | 1 | 07-027 | 1.2.2.3.1.1 | HOWARD F |  |  |  |  |  |  |  |  |  |  |
| 122311908LOE |  | FY08 Overview Entire PED Proj Q1-QUAD |  | 248d | 2007-10-01 | 2008-09-30 | 122311007LOE, 9-080M | 0d |  | SCIENTIST [1036 h] | 64,511.72 | FENKER H | 1 | 1 |  | 1.2.2.3.1.1 | HOWARD F |  |  |  |  |  |  |  |  |  |  |
| 122311045b |  | P-2 Prep reference Dsgn Q1-QUAD |  | 122d | 2007-11-29 | 2008-05-30 | 122311045, 9-080M | 17d | 0d | MECH ENG [120 h]; MECH DES [40 h] | 9,120 | FENKER H | 1 | 1 | 07-027 | 1.2.2.3.1.1 | HOWARD F |  |  |  |  |  |  |  |  |  |  |
| 122311049 |  | Dsgn Mag SupprtStand Q1-QUAD |  | 55d | 2008-01-11 | 2008-03-31 | 9-080M, 122311047 | 60d | 43d | MECH DES [360 h]; MECH ENG [40 h] | 17,766.4 | FENKER H | 1 | 1 | 07-027 | 1.2.2.3.1.1 | HOWARD F |  |  |  |  |  |  |  |  |  |  |
| 122311045M |  | Reference Dsgn Comptd Q1-QUAD | milestone | 0d | 2008-05-30 | 2008-05-30 | 122311045b | 17d | 0d |  |  | FENKER H | 1 | 1 | 07-027 | 1.2.2.3.1.1 | HOWARD F |  |  |  |  |  |  |  | 6 |  |  |
| 122311050M |  | Start Bid Process Q1-QUAD | milestone | 0d | 2008-06-02 | 2008-06-02 | 122311045M | 17d | 0d |  |  | FENKER H | 1 | 1 | 07-027 | 1.2.2.3.1.1 | HOWARD F |  |  |  |  |  |  |  | 6 |  |  |
| 122311055 |  | FY08 Exp Bid Process P-#1 Q1-QUAD |  | 85d | 2008-06-02 | 2008-09-30 | 122311050M, 122311049 | 17d | 0d | TRAVEL; MECH DES [215.87 h]; MECH ENG [539.68 h]; SUPPLIES & MATERIALS | 49,010.95 | FENKER H | 1 | 1 | 07-027 | 1.2.2.3.1.1 | HOWARD F | EXP0809 |  |  |  |  |  |  |  |  |  |
| 122311055a |  | FY09 Exp Bid Process P-#1 Q1-QUAD |  | 41d | 2008-10-01 | 2008-11-26 | 122311055 | 17d | 0d | MECH DES [104.13 h]; MECH ENG [260.32 h]; SUPPLIES & MATERIALS; TRAVEL | 24,394.96 | FENKER H | 1 | 1 | 07-027 | 1.2.2.3.1.1 | HOWARD F | EXP0809 |  |  |  |  |  |  |  |  |  |
| 14312909LOEX |  | Q1- FY09 Proj Mngmnt H-C upgrade |  | 59d | 2008-10-01 | 2008-12-24 | 122311908LOE | 20d | 0d | SCIENTIST [105.25 h] | 6,763.37 | FENKER H | 1 | 1 |  |  | HOWARD F |  |  |  |  |  |  |  |  | 08-058 | 12-012 |
| 122311056 |  | Determine Best Offer P-#2 Q1-QUAD+ |  | 50d | 2008-12-01 | 2009-02-18 | 122311055a | 17d |  |  |  | FENKER H | 1 | 1 | 07-027 | 1.2.2.3.1.1 | HOWARD F |  |  |  |  |  |  |  |  |  |  |
| 122311060 |  | Re-Baseline Actuals Adjustment |  | 1d | 2013-08-30 | 2013-08-30 | 9-130M FS+227d | 20d |  | PROCUREMENT>$50K 69 NO ESCALATION | 190,395.4 | FENKER H | 1 | 1 |  |  | HOWARD F |  |  | 13-014 | ADJ |  |  |  |  |  |  |

| ID | WBS | Activity | Type | Duration | Start | Finish | Predecessors | Total float | Free float | Resources | Cost | Planned FinishUDF | RESP - Responsibility | STRT%COMP for CM EVM | FNSH%COMP for CM EVM | CR 07-005 | WBS ASSIGNMENT | CAM RESPONSIBLE | CR 07-027 | Milestone Level | Profile change | CR 08-042 | CR 07-034 | CR 08-048 | CR 09-008 | CR 10-069 | CR 10-076 | CR 11-017 | CR 11-026 | CR 12-012 | CR 12-036 | CR 11-046 | CR 13-006 | ACT BRIDGING FY SPLIT | CR 13-014 | ReBaseline Actuals Adjustment |
| --- | --- | --- | --- | --- | --- | --- | --- | --- | --- | --- | --- | --- | --- | --- | --- | --- | --- | --- | --- | --- | --- | --- | --- | --- | --- | --- | --- | --- | --- | --- | --- | --- | --- | --- | --- | --- |
|  | 2 | **1.2.2.3.1.2 HB/Q2-3/DIPOLE** |  |  | 2006-10-02 | 2013-08-30 |  |  |  |  |  |  |  |  |  |  |  |  |  |  |  |  |  |  |  |  |  |  |  |  |  |  |  |  |  |  |
| 122312015 |  | Optimise coil design analyze tolerances HB/Q2-3/Dipole |  | 120d | 2006-10-02 | 2007-03-30 | 9-070M | 105d | 0d | MECH DES [667.2 h]; MECH ENG [194.68 h] | 41,600.42 | 2007-03-30 | FENKER H | 1 | 1 | 07-005 | 1.2.2.3.1.2 | HOWARD F |  |  |  |  |  |  |  |  |  |  |  |  |  |  |  |  |  |  |
| 122312050 |  | Prepare reference design Q2-3/Dipole |  | 206d | 2006-10-02 | 2007-08-01 | 9-070M | 57d | 0d | MECH ENG [320 h]; MECH DES [160 h]; SUPPLIES & MATERIALS | 28,417.5 | 2007-08-01 | FENKER H | 1 | 1 | 07-005 | 1.2.2.3.1.2 | HOWARD F |  |  |  |  |  |  |  |  |  |  |  |  |  |  |  |  |  |  |
| 122312060 |  | Optimize Coil Design for HB Magnet (HB) |  | 84d | 2006-10-02 | 2007-02-07 | 9-070M | 251d | 163d | MECH ENG [240 h]; MECH DES [121.2 h] | 20,195.2 | 2007-09-26 | FENKER H | 1 | 1 | 07-005 | 1.2.2.3.1.2 | HOWARD F |  |  |  |  |  |  |  |  |  |  |  |  |  |  |  |  |  |  |
| 122312035 |  | Design LN2 shield HB/Q2-3/Dipole |  | 59d | 2007-03-30 | 2007-06-21 | 122312030 FS-40d | 105d | 48d | MECH DES [480 h]; MECH ENG [40 h] | 23,476.69 | 2007-08-17 | FENKER H | 1 | 1 | 07-005 | 1.2.2.3.1.2 | HOWARD F | 07-027 |  |  |  |  |  |  |  |  |  |  |  |  |  |  |  |  |  |
| 122312030 |  | Design helium vessel (HB/Q2-3/Dipole) |  | 39d | 2007-04-02 | 2007-05-24 | 122312015 | 105d | 0d | MECH DES [131.88 h]; PROCUREMENT<$50K 60 | 35,767.11 | 2007-05-24 | FENKER H | 1 | 1 | 07-005 | 1.2.2.3.1.2 | HOWARD F | 07-027 |  |  |  |  |  |  |  |  |  |  |  |  |  |  |  |  |  |
| 122312050M |  | Reference design completed Q2-3/Dipole | milestone | 0d | 2007-08-01 | 2007-08-01 | 122312050, 1141015, 1141020 | 57d | 0d |  |  | 2007-08-01 | FENKER H | 1 | 1 | 07-005 | 1.2.2.3.1.2 | HOWARD F |  | 5 | C |  |  |  |  |  |  |  |  |  |  |  |  |  |  |  |
| 122312045 |  | P-1 Dsgn Mag Supprt & Stand Q2-3/Dipole |  | 29d | 2007-08-02 | 2007-09-12 | 122312035 FS-20d, 122312050M | 57d | 0d | MECH DES [192 h]; PROCUREMENT<$50K 60; MECH ENG [16 h] | 33,153.71 | 2007-09-28 | FENKER H | 1 | 1 | 07-005 | 1.2.2.3.1.2 | HOWARD F |  |  |  |  |  |  |  |  |  |  |  |  |  |  |  |  |  |  |
| 122312045b |  | P-2 Dsgn Mag Supprt & Stand Q2-3/Dipole |  | 43d | 2007-09-13 | 2007-11-12 | 122312045 | 57d | 0d | MECH DES [40 h] | 1,684.59 |  | FENKER H | 1 | 1 |  | 1.2.2.3.1.2 | HOWARD F |  |  |  |  |  |  |  |  |  |  |  |  |  |  |  |  |  |  |
| 122312062M |  | Start Bid Process Q2-3/Dipole | milestone | 0d | 2007-10-01 | 2007-10-01 | 1141010, 1141015, 9-080M, 1141020, 122312060 | 88d | 31d |  |  |  | FENKER H | 1 | 1 |  | 1.2.2.3.1.2 | HOWARD F |  | 6 |  |  |  |  |  |  |  |  |  |  |  |  |  |  |  |  |
| 122312074 |  | Dsgn Cryostat for Horiz Bender (HB) |  | 60d | 2007-10-01 | 2008-01-03 | 9-080M | 366d | 221d | MECH DES [200 h]; MECH ENG [40 h] | 10,969.6 |  | FENKER H | 1 | 1 |  | 1.2.2.3.1.2 | HOWARD F |  |  |  |  |  |  |  |  |  |  |  |  |  |  |  |  |  |  |
| 122312076 |  | Dsgn quench Detection Sys for Horiz Bender (HB) |  | 39d | 2007-10-01 | 2007-11-26 | 9-080M | 387d | 242d | PROCUREMENT<$50K 60; MECH ENG [40 h] | 26,057.67 |  | FENKER H | 1 | 1 |  | 1.2.2.3.1.2 | HOWARD F |  |  |  |  |  |  |  |  |  |  |  |  |  |  |  |  |  |  |
| 122312078 |  | Dsgn Supprt & Stand for Horiz Bender (HB) |  | 60d | 2007-10-01 | 2008-01-03 | 9-080M | 366d | 221d | MECH DES [440 h]; MECH ENG [40 h] | 21,164.8 |  | FENKER H | 1 | 1 |  | 1.2.2.3.1.2 | HOWARD F |  |  |  |  |  |  |  |  |  |  |  |  |  |  |  |  |  |  |
| 122312079 |  | CR 07-005 Procurements P-1 Dipole |  | 100d | 2007-10-01 | 2008-03-03 | 9-080M | 276d | 0d | PROCUREMENT<$50K 60 | 32,984.68 |  | FENKER H | 1 | 1 |  | 1.2.2.3.1.2 | HOWARD F |  |  | C |  |  |  |  |  |  |  |  |  |  |  |  |  |  |  |
| 122312080 |  | Prepare Preliminary Dsgn for HB |  | 117d | 2007-10-01 | 2008-03-26 | 9-080M | 89d | 46d | MECH ENG [120 h]; MECH DES [40 h]; SUPPLIES & MATERIALS | 12,215.7 |  | FENKER H | 1 | 1 |  | 1.2.2.3.1.2 | HOWARD F |  |  |  | 08-042 |  |  |  |  |  |  |  |  |  |  |  |  |  |  |
| 122312065 |  | Bid Process P-#1 Q2-3/Dipole |  | 140d | 2007-11-13 | 2008-06-11 | 122312045b, 122312062M | 57d | 0d | SUPPLIES & MATERIALS; MECH ENG [120 h]; MECH DES [320 h]; TRAVEL | 36,069.82 |  | FENKER H | 1 | 1 |  | 1.2.2.3.1.2 | HOWARD F |  |  |  |  |  |  |  |  |  |  |  |  |  |  |  |  |  |  |
| 122312084 |  | CR 07-005 Procurements P-2 Dipole |  | 100d | 2008-03-04 | 2008-07-23 | 122312079 | 276d | 131d | PROCUREMENT<$50K 60 | 32,984.68 |  | FENKER H | 1 | 1 |  | 1.2.2.3.1.2 | HOWARD F | 07-027 |  |  |  |  |  |  |  |  |  |  |  |  |  |  |  |  |  |
| 122312080a |  | Prepare Reference Dsgn for HB |  | 139d | 2008-05-01 | 2008-11-14 | 9-080M FS+142d | 145d | 0d | PROCUREMENT<$50K 60 NO ESCALATION FY09; PROCUREMENT>$50K 69 NO ESCALATION FY09 | 90,000 |  | FENKER H | 1 | 1 |  | 1.2.2.3.1.2 | HOWARD F |  |  |  | 08-042 |  |  |  |  |  |  |  |  |  |  |  |  |  |  |
| 122312070 |  | Determine Best Offer P-#2 Q2-3/Dipole |  | 60d | 2008-06-12 | 2008-09-05 | 1141011, 122312065 | 57d |  |  |  |  | FENKER H | 1 | 1 |  | 1.2.2.3.1.2 | HOWARD F | 07-027 |  | C |  |  |  |  |  |  |  |  |  |  |  |  |  |  |  |
| 122312080M |  | Reference Dsgn for Horiz Bender Comptd (HB) | milestone | 0d | 2008-11-14 | 2008-11-14 | 122312080a, 122312076, 122312080 | 145d | 0d |  |  |  | FENKER H | 1 | 1 |  | 1.2.2.3.1.2 | HOWARD F |  | 6 |  | 08-042 |  |  |  |  |  |  |  |  |  |  |  |  |  |  |
| 122312090 |  | Bid Process for Horiz Bender P-#1 (HB) |  | 50d | 2008-11-17 | 2009-02-05 | 122312078, 122312074, 122312080M | 145d | 0d | MECH DES [120 h]; MECH ENG [280 h] | 23,127.6 |  | FENKER H | 1 | 1 |  | 1.2.2.3.1.2 | HOWARD F |  |  |  | 08-042 |  |  |  |  |  |  |  |  |  |  |  |  |  |  |
| 14315050x |  | Design Cryo Reservoirs for All Mag |  | 80d | 2008-12-01 | 2009-04-01 | 9-090M FS+41d | 346d | 0d | MECH DES [480 h]; MECH ENG [880 h] | 77,196 |  | FENKER H | 1 | 1 |  |  | HOWARD F |  |  |  |  | 07-034 | 08-048 | 09-008 | 10-069 | 10-076 | 11-017 | 11-026 | 12-012 | 12-036F |  |  |  |  |  |
| 14315055x |  | Design Iron Yoke for Q2/3 and Dipole |  | 60d | 2008-12-01 | 2009-03-04 | 9-090M FS+41d | 692d | 0d | MECH ENG [420 h]; MECH DES [224 h] | 36,620.36 |  | FENKER H | 1 | 1 |  |  | HOWARD F |  |  |  |  | 07-034 | 08-048 | 09-008 | 10-069 | 10-076 |  | 11-026 | 12-012 | 12-036F | 11-046 | 13-006F |  |  |  |
| 122312095 |  | Determine Best Offer for Horiz Bender P-#2 (HB) |  | 20d | 2009-02-06 | 2009-03-06 | 122312090, 1141012, 122312084 | 145d |  |  |  |  | FENKER H | 1 | 1 |  | 1.2.2.3.1.2 | HOWARD F | 07-027 |  | C | 08-042 |  |  |  |  |  |  |  |  |  |  |  | FY08-09 |  |  |
| 122312100 |  | Re-Baseline Actuals Adjustment |  | 1d | 2013-08-30 | 2013-08-30 | 9-130M FS+227d | 20d |  | PROCUREMENT>$50K 69 NO ESCALATION | 91,235.22 |  | FENKER H | 1 | 1 |  |  | HOWARD F |  |  |  |  |  |  |  |  |  |  |  |  |  |  |  |  | 13-014 | ADJ |

Notes:
- 122312050M: Corrective Actions: Removed Predcessor - Activity / 1141010. 23 April 2007 (PMC)
- 122312079: Corrective Actions: 02 Mar 2007 Reduced uner 50k per Val. From 40,870 to 31,965 / (PMC)
- 122312084: Corrective Actions: 02 Mar 2007 Reduced uner 50k per Val. From 40,870 to 31,965 / (PMC)
- 14315050x: Steps: Preliminary Design; Engineering Calculations; Final Drawings; Bid Package

| ID | WBS | Activity | Type | Duration | Start | Finish | Predecessors | Total float | Free float | Resources | Cost | Planned FinishUDF | RESP - Responsibility | STRT%COMP for CM EVM | FNSH%COMP for CM EVM | CR 07-002 | CAM RESPONSIBLE | CR 07-027 | CR 13-014 | ReBaseline Actuals Adjustment | CR 10-069 | CR 11-026 | CR 11-046 | CR 12-012 | CR 08-016 | EXPNS ACT BRIDGING FY SPLIT | CR 09-012 | Milestone Level |
| --- | --- | --- | --- | --- | --- | --- | --- | --- | --- | --- | --- | --- | --- | --- | --- | --- | --- | --- | --- | --- | --- | --- | --- | --- | --- | --- | --- | --- |
|  | 2 | **1.2.2.3.2 DETECTOR** |  |  | 2007-01-04 | 2013-08-30 |  |  |  |  |  |  |  |  |  |  |  |  |  |  |  |  |  |  |  |  |  |  |
| 122321005 |  | P-1 Update and rescale existing drawings (WIRE CHAMB) |  | 187d | 2007-01-04 | 2007-09-28 | 9-070M FS+60d | 248d |  | SCIENTIST [80 h] | 5,013.77 | 2007-09-28 | FENKER H | 1 | 1 | 07-002 | HOWARD F |  |  |  |  |  |  |  |  |  |  |  |
| 122322005 |  | Update drawings for scintillator (HODO) |  | 130d | 2007-01-04 | 2007-07-10 | 9-070M FS+60d | 333d | 0d | SCIENTIST [80 h] | 5,095.4 | 2007-07-10 | FENKER H | 1 | 1 | 07-002 | HOWARD F | 07-027 |  |  |  |  |  |  |  |  |  |  |
| 122325005 |  | Prepare drawings for final block arrangements (SHWR CNTR) |  | 60d | 2007-01-04 | 2007-03-30 | 9-070M FS+60d | 603d |  | TRAVEL; SCIENTIST [63.2 h]; VISTNG USERS [366.8 h] | 12,959.44 | 2007-03-30 | FENKER H | 1 | 1 | 07-002 | HOWARD F |  |  |  |  |  |  |  |  |  |  |  |
| 122322015 |  | P-1 Prep Drawings for Quartz hosdoscope (HODO) |  | 57d | 2007-05-14 | 2007-08-02 | 1142025, 9-070M, 122322005 FS-40d | 333d | 288d | TRAVEL; SCIENTIST [28 h]; PLABOR; VISTNG USERS [184 h] | 7,358.27 | 2007-09-28 | FENKER H | 1 | 1 | 07-002 | HOWARD F |  |  |  |  |  |  |  |  |  |  |  |
| 122323005 |  | P-1 Update existing drawings for Cerenkov (HIPRESS CRNKV) |  | 73d | 2007-06-18 | 2007-09-28 | 9-070M FS+174d | 275d | 248d | SCIENTIST [68 h] | 4,133.22 | 2007-09-28 | FENKER H | 1 | 1 | 07-002 | HOWARD F |  |  |  |  |  |  |  |  |  |  |  |
| 12232015 |  | P-2 Update & Rescale Existing Drawings (Wire CHAMB)+ |  | 228d | 2008-10-01 | 2009-09-01 | 122321005, 9-090M | 0d |  | SCIENTIST [80 h] | 5,140.8 |  | FENKER H | 1 | 1 |  | HOWARD F | 07-027 |  |  |  |  |  |  |  |  |  |  |
| 122322015b |  | P-2 Prep Drawings for Quartz Hodoscope (HODO)+ |  | 203d | 2008-10-01 | 2009-07-28 | 9-090M, 122322015 | 45d |  | TRAVEL; SCIENTIST [92 h]; PLABOR; VISTNG USERS [644 h] | 27,888.05 |  | FENKER H | 1 | 1 |  | HOWARD F | 07-027 |  |  |  |  |  |  |  |  |  |  |
| 122323005b |  | P-2 Update Existing Drawings for Cerenkov (HIPRESS CRNKV) |  | 11d | 2008-10-01 | 2008-10-15 | 122323005, 9-090M | 27d | 0d | SCIENTIST [12 h] | 771.12 |  | FENKER H | 1 | 1 |  | HOWARD F | 07-027 |  |  |  |  |  |  |  |  |  |  |
| 122325015 |  | Prep Drawings for PM & Cable Arrangement (SHWR CNTR) |  | 129d | 2008-10-20 | 2009-04-30 | 9-090M FS+13d | 1d | 0d | TRAVEL; PLABOR; SCIENTIST [48 h]; VISTNG USERS [240 h] | 10,883.87 |  | FENKER H | 1 | 1 |  | HOWARD F | 07-027 |  |  |  |  |  |  |  |  |  |  |
| 122324005 |  | P-1 Prepare drawings for heavy gas Cerenkove (LOPRESS CRNKV) |  | 52d | 2009-01-05 | 2009-03-19 | 1142020, 9-090M FS+60d | 65d | 0d | SCIENTIST [68 h] | 4,369.68 | 2007-09-28 | FENKER H | 1 | 1 | 07-002 | HOWARD F | 07-027 |  |  |  |  |  |  |  |  |  |  |
| 122323015 |  | Update Existing Drawers for Cerenkov (HIPRESS CRNKV)+ |  | 130d | 2009-02-19 | 2009-08-21 | 122323005b FS+80d | 27d |  | SCIENTIST [120 h] | 7,711.2 |  | FENKER H | 1 | 1 |  | HOWARD F | 07-027 |  |  |  |  |  |  |  |  |  |  |
| 122324005b |  | P-2 Prep Drawings for Heavy Gas Cerenkove (LOPRESS CRNKV) |  | 11d | 2009-03-20 | 2009-04-03 | 122324005 | 65d | 0d | SCIENTIST [12 h] | 771.12 |  | FENKER H | 1 | 1 |  | HOWARD F |  |  |  |  |  |  |  |  |  |  |  |
| 122324015 |  | Prep Drawings for Heavy Gas Cerenkove (LOPRESS CRNKV)+ |  | 60d | 2009-04-06 | 2009-06-29 | 122324005b | 65d |  | SCIENTIST [120 h] | 7,711.2 |  | FENKER H | 1 | 1 |  | HOWARD F | 07-027 |  |  |  |  |  |  |  |  |  |  |
| 122325020 |  | Dsgn Detector Frame (SHWR CNTR)++ |  | 105d | 2009-05-01 | 2009-09-29 | 122325015 | 1d |  | PROCUREMENT<$50K 60 | 19,166.72 |  | FENKER H | 1 | 1 |  | HOWARD F | 07-027 |  |  |  |  |  |  |  |  |  |  |
| 12232020 |  | P-3 Update & Rescale Existing Drawings (Wire CHAMB) + |  | 20d | 2009-09-02 | 2009-09-30 | 122325005, 12232015 | 0d |  | SCIENTIST [40 h] | 2,570.4 |  | FENKER H | 1 | 1 |  | HOWARD F | 07-027 |  |  |  |  |  |  |  |  |  |  |
| 122325025 |  | Re-Baseline Actuals Adjustment |  | 1d | 2013-08-30 | 2013-08-30 | 9-130M FS+227d | 20d |  | PROCUREMENT>$50K 69 NO ESCALATION | -15,172.56 |  | FENKER H | 1 | 1 |  | HOWARD F |  | 13-014 | ADJ |  |  |  |  |  |  |  |  |
|  | 1 | **1.2.2.3.2.1 WIRE CHAMBERS** |  |  |  |  |  |  |  |  |  |  |  |  |  |  |  |  |  |  |  |  |  |  |  |  |  |  |
|  | 2 | **1.2.2.3.2.2 HODOSCOPES** |  |  |  |  |  |  |  |  |  |  |  |  |  |  |  |  |  |  |  |  |  |  |  |  |  |  |
|  | 3 | **1.2.2.3.2.3 HIGH PRESSURE CERENKOV (Atm.Press.Cerenkov)** |  |  |  |  |  |  |  |  |  |  |  |  |  |  |  |  |  |  |  |  |  |  |  |  |  |  |
|  | 4 | **1.2.2.3.2.4 LOW PRESSURE CERENKOV (Heavy Gas Cerenkov))** |  |  |  |  |  |  |  |  |  |  |  |  |  |  |  |  |  |  |  |  |  |  |  |  |  |  |
|  | 5 | **1.2.2.3.2.5 SHOWER COUNTER** |  |  |  |  |  |  |  |  |  |  |  |  |  |  |  |  |  |  |  |  |  |  |  |  |  |  |
|  | 6 | **1.2.2.3.2.6 AEROGEL CERENKOV** |  |  |  |  |  |  |  |  |  |  |  |  |  |  |  |  |  |  |  |  |  |  |  |  |  |  |
|  | 7 | **1.2.2.3.2.7 TRD** |  |  |  |  |  |  |  |  |  |  |  |  |  |  |  |  |  |  |  |  |  |  |  |  |  |  |
|  | 8 | **1.2.2.3.2.8 DETECTOR FRAME** |  |  |  |  |  |  |  |  |  |  |  |  |  |  |  |  |  |  |  |  |  |  |  |  |  |  |
|  | 3 | **1.2.2.3.3 COMPUTING** |  |  |  |  |  |  |  |  |  |  |  |  |  |  |  |  |  |  |  |  |  |  |  |  |  |  |
|  | 1 | **1.2.2.3.3.1 DAQ** |  |  |  |  |  |  |  |  |  |  |  |  |  |  |  |  |  |  |  |  |  |  |  |  |  |  |
|  | 2 | **1.2.2.3.3.2 SLOW CONTROLS** |  |  |  |  |  |  |  |  |  |  |  |  |  |  |  |  |  |  |  |  |  |  |  |  |  |  |
|  | 4 | **1.2.2.3.4 ELECTRONICS** |  |  |  |  |  |  |  |  |  |  |  |  |  |  |  |  |  |  |  |  |  |  |  |  |  |  |
|  | 1 | **1.2.2.3.4.1 FAST ELECTRONICS** |  |  |  |  |  |  |  |  |  |  |  |  |  |  |  |  |  |  |  |  |  |  |  |  |  |  |
|  | 2 | **1.2.2.3.4.2 POWER SUPPLIES & PROBES** |  |  |  |  |  |  |  |  |  |  |  |  |  |  |  |  |  |  |  |  |  |  |  |  |  |  |
|  | 5 | **1.2.2.3.5 BEAMLINE** |  |  |  |  |  |  |  |  |  |  |  |  |  |  |  |  |  |  |  |  |  |  |  |  |  |  |
|  | 1 | **1.2.2.3.5.1 MOELLER** |  |  |  |  |  |  |  |  |  |  |  |  |  |  |  |  |  |  |  |  |  |  |  |  |  |  |
|  | 2 | **1.2.2.3.5.2 COMPTON** |  |  |  |  |  |  |  |  |  |  |  |  |  |  |  |  |  |  |  |  |  |  |  |  |  |  |
|  | 3 | **1.2.2.3.5.3 MAPPING** |  |  |  |  |  |  |  |  |  |  |  |  |  |  |  |  |  |  |  |  |  |  |  |  |  |  |
|  | 4 | **1.2.2.3.5.4 SCATTERING CHAMBER** |  |  |  |  |  |  |  |  |  |  |  |  |  |  |  |  |  |  |  |  |  |  |  |  |  |  |
|  | 5 | **1.2.2.3.5.5 BEAM PIPE & STANDS** |  |  |  |  |  |  |  |  |  |  |  |  |  |  |  |  |  |  |  |  |  |  |  |  |  |  |
|  | 6 | **1.2.2.3.5.6 MAGNET POWER SUPPLY** |  |  |  |  |  |  |  |  |  |  |  |  |  |  |  |  |  |  |  |  |  |  |  |  |  |  |
|  | 6 | **1.2.2.3.6 INFRASTRUCTURE** |  |  | 2006-10-02 | 2013-08-30 |  |  |  |  |  |  |  |  |  |  |  |  |  |  |  |  |  |  |  |  |  |  |
| 122362010 |  | Hire subcontructor to prepare preliminmary design (SUP STRUCT) |  | 89d | 2006-10-02 | 2007-02-14 | 9-070M | 154d | 0d | PROCUREMENT<$50K 60 | 10,320 | 2007-02-14 | FENKER H | 1 | 1 | 07-002 | HOWARD F |  |  |  |  |  |  |  |  |  |  |  |
| 122363010 |  | Prepare preliminary drawings (SHLD HOUSE) |  | 82d | 2006-10-02 | 2007-02-05 | 9-070M | 160d | 0d | MECH ENG [64.44 h]; MECH DES [71.48 h]; PROCUREMENT<$50K 60 | 17,793.7 | 2007-02-05 | FENKER H | 1 | 1 | 07-002 | HOWARD F |  |  |  |  |  |  |  |  |  |  |  |
| 122363015 |  | Approve preliminary design (SHLD HOUSE) |  | 5d | 2007-02-06 | 2007-02-12 | 122363010 | 160d |  | MECH DES [40 h]; MECH ENG [40 h]; TRAVEL | 6,311.6 | 2007-02-12 | FENKER H | 1 | 1 | 07-002 | HOWARD F |  |  |  |  |  |  |  |  |  |  |  |
| 122362015 |  | Approve preliminary design (SUP STRUCT) |  | 5d | 2007-02-15 | 2007-02-22 | 122362010 | 154d | 153d | MECH ENG [40 h]; TRAVEL; MECH DES [40 h] | 6,307.6 | 2007-02-22 | FENKER H | 1 | 1 | 07-002 | HOWARD F |  |  |  |  |  |  |  |  |  |  |  |
| 122361010 |  | P-1 Dsgn Vac Sys (ENG&DES)+ |  | 117d | 2007-04-16 | 2007-09-28 | 9-070M FS+130d | 386d | 248d | MECH DES [220 h]; SUPPLIES & MATERIALS; MECH ENG [110 h] | 18,080.89 | 2007-09-28 | FENKER H | 1 | 1 | 07-002 | HOWARD F | 07-027 |  |  | 10-069 | 11-026 | 11-046 | 12-012 |  |  |  |  |
| 122361015 |  | P-1 Dsgn Cryogenic Sys (ENG&DES)+ |  | 117d | 2007-04-16 | 2007-09-28 | 9-070M FS+130d | 486d | 248d | MECH DES [148 h]; SUPPLIES & MATERIALS; MECH ENG [72 h] | 12,717.19 | 2007-09-28 | FENKER H | 1 | 1 | 07-002 | HOWARD F | 07-027 |  |  |  |  |  |  |  |  |  |  |
| 122362020 |  | Produce detailed design and drawings (SUP STRUCT) |  | 110d | 2007-10-01 | 2008-03-17 | 9-080M, 122362015 | 1d | 0d | MECH ENG [113.6 h]; MECH DES [280.4 h]; PROCUREMENT<$50K 60 | 46,281.76 | 2007-09-28 | FENKER H | 1 | 1 | 07-002 | HOWARD F | 07-027 |  |  |  |  |  |  |  |  |  |  |
| 122363020 |  | Prepare detailed design and drawings (SHLD HOUSE) |  | 120d | 2007-10-01 | 2008-03-31 | 122363015, 9-080M | 0d |  | PROCUREMENT<$50K 60; MECH ENG [80 h]; MECH DES [80 h] | 30,712.03 | 2007-09-28 | FENKER H | 1 | 1 | 07-002 | HOWARD F | 07-027 |  |  |  |  |  |  |  |  |  |  |
| 12236030 |  | PROC Continue Reference Dsgn & Drawings (SUP STRUCT) |  | 240d | 2008-03-18 | 2009-03-05 | 122362020 | 1d | 0d | PROCUREMENT<$50K 60 NO ESCALATION FY09 | 25,560.16 |  | FENKER H | 1 | 1 |  | HOWARD F | 07-027 |  |  |  |  |  |  | 08-016 | EXP0809 | 09-012 |  |
| 12236030a |  | FY08 Exp Continue Reference Dsgn & Drawings (SUP STRUCT) |  | 138d | 2008-03-18 | 2008-09-30 | 122362020 | 1d | 0d | TRAVEL; MECH DES [115 h]; MECH ENG [50.6 h] | 9,200.99 |  | FENKER H | 1 | 1 |  | HOWARD F | 07-027 |  |  |  |  |  |  | 08-016 | EXP0809 |  |  |
| 12236045 |  | PROC Continue Reference Dsgn & Drawings (SHLD HOUSE) |  | 240d | 2008-04-01 | 2009-03-19 | 122363020 | 0d |  | PROCUREMENT<$50K 60 NO ESCALATION FY09 | 21,298.42 |  | FENKER H | 1 | 1 |  | HOWARD F | 07-027 |  |  |  |  |  |  | 08-016 | EXP0809 | 09-012 |  |
| 12236045a |  | FY08 Exp Continue Reference Dsgn & Drawings (SHLD HOUSE) |  | 128d | 2008-04-01 | 2008-09-30 | 122363020 | 0d |  | MECH ENG [42.67 h]; TRAVEL; MECH DES [42.67 h] | 5,552.02 |  | FENKER H | 1 | 1 |  | HOWARD F | 07-027 |  |  |  |  |  |  | 08-016 | EXP0809 |  |  |
| 12236010b |  | P-2 Dsgn Vac Sys (ENG&DES)+ |  | 10d | 2008-10-01 | 2008-10-14 | 122361010, 9-090M | 138d | 50d | SUPPLIES & MATERIALS; MECH DES [19.6 h]; MECH ENG [0.4 h] | 3,014.42 |  | FENKER H | 1 | 1 |  | HOWARD F | 07-027 |  |  | 10-069 | 11-026 | 11-046 | 12-012 |  |  |  |  |
| 12236015b |  | P-2 Dsgn Cryogenic Sys (ENG&DES)+ |  | 10d | 2008-10-01 | 2008-10-14 | 9-090M, 122361015 | 238d |  | SUPPLIES & MATERIALS; MECH ENG [8 h]; MECH DES [12 h] | 3,166.2 |  | FENKER H | 1 | 1 |  | HOWARD F | 07-027 |  |  |  |  |  |  |  |  |  |  |
| 12236020 |  | Dsgn Scattering Chamb (ENG&DES)+ |  | 20d | 2008-10-01 | 2008-10-28 | 9-090M | 128d | 40d | MECH DES [80 h]; SUPPLIES & MATERIALS; MECH ENG [40 h] | 8,189.24 |  | FENKER H | 1 | 1 |  | HOWARD F | 07-027 |  |  | 10-069 | 11-026 | 11-046 | 12-012 |  |  |  |  |
| 12236025 |  | Dsgn Beam Pipe & Stands (ENG&DES)+ |  | 60d | 2008-10-01 | 2009-01-02 | 9-090M | 88d | 0d | SUPPLIES & MATERIALS; MECH ENG [80 h]; MECH DES [160 h] | 14,248.84 |  | FENKER H | 1 | 1 |  | HOWARD F | 07-027 |  |  | 10-069 | 11-026 | 11-046 | 12-012 |  |  |  |  |
| 12236030b |  | FY09 Exp Continue Reference Dsgn & Drawings (SUP STRUCT) |  | 102d | 2008-10-01 | 2009-03-05 | 12236030a | 1d | 0d | TRAVEL; MECH DES [85 h]; MECH ENG [37.4 h] | 7,017.99 |  | FENKER H | 1 | 1 |  | HOWARD F | 07-027 |  |  |  |  |  |  | 08-016 | EXP0809 |  |  |
| 12236045b |  | FY09 Exp Continue Reference Dsgn & Drawings (SHLD HOUSE) |  | 112d | 2008-10-01 | 2009-03-19 | 12236045a | 0d |  | TRAVEL; MECH DES [37.33 h]; MECH ENG [37.33 h] | 5,012.41 |  | FENKER H | 1 | 1 |  | HOWARD F | 07-027 |  |  |  |  |  |  | 08-016 | EXP0809 |  |  |
| 12236830LOE |  | FY09 Coordinate All SHMS Compnts with Supprt Struct (ENG&DES)+ |  | 189d | 2008-10-01 | 2009-07-08 | 9-090M | 59d |  | TRAVEL; PLABOR; PROCUREMENT<$50K 60; MECH ENG [80 h]; MECH DES [160 h] | 35,225.74 |  | FENKER H | 1 | 1 |  | HOWARD F | 07-027 |  |  |  |  |  |  |  |  |  |  |
| 12236035 |  | Prep Bid Packages (SUP STRUCT) |  | 80d | 2009-03-06 | 2009-06-26 | 12236030b, 12236030 | 1d | 0d | SUPPLIES & MATERIALS; MECH ENG [80 h]; MECH DES [160 h] | 15,846.06 |  | FENKER H | 1 | 1 |  | HOWARD F | 07-027 |  |  |  |  |  |  |  |  |  |  |
| 12236050 |  | Prep Bid Packages (SHLD HOUSE) |  | 80d | 2009-03-20 | 2009-07-13 | 12236045b, 12236045 | 0d |  | MECH DES [80 h]; SUPPLIES & MATERIALS; MECH ENG [80 h] | 12,338.86 |  | FENKER H | 1 | 1 |  | HOWARD F | 07-027 |  |  |  |  |  |  |  |  |  |  |
| 12236035M |  | Start Bid Process (SUP STRUCT) | milestone | 0d | 2009-06-29 | 2009-06-29 | 12236035 | 1d | 0d |  |  |  | FENKER H | 1 | 1 |  | HOWARD F | 07-027 |  |  |  |  |  |  |  |  |  | 6 |
| 12236040 |  | Determine Best Offer (SUP STRUCT)+ |  | 65d | 2009-06-29 | 2009-09-29 | 12236035M | 1d |  | MECH DES [40 h]; TRAVEL; MECH ENG [40 h] | 6,435.64 |  | FENKER H | 1 | 1 |  | HOWARD F | 07-027 |  |  |  |  |  |  |  |  |  |  |
| 12236055M |  | Start Bid Process (SHLD HOUSE) | milestone | 0d | 2009-07-14 | 2009-07-14 | 12236050 | 0d |  |  |  |  | FENKER H | 1 | 1 |  | HOWARD F | 07-027 |  |  |  |  |  |  |  |  |  | 6 |
| 12236060 |  | Determine Best Offer (SHLD HOUSE)+ |  | 56d | 2009-07-14 | 2009-09-30 | 12236055M | 0d |  | MECH DES [40 h]; TRAVEL; MECH ENG [40 h] | 6,435.64 |  | FENKER H | 1 | 1 |  | HOWARD F | 07-027 |  |  |  |  |  |  |  |  |  |  |
| 122363025 |  | Re-Baseline Actuals Adjustment |  | 1d | 2013-08-30 | 2013-08-30 | 9-130M FS+227d | 20d |  | PROCUREMENT>$50K 69 NO ESCALATION | -38,064.45 |  | FENKER H | 1 | 1 |  | HOWARD F |  | 13-014 | ADJ |  |  |  |  |  |  |  |  |

| ID | WBS | Activity | Type | Duration | Start | Finish | Predecessors | Total float | Free float | Constraint | Resources | Cost | RESP - Responsibility | STRT%COMP for CM EVM | FNSH%COMP for CM EVM | HALL D Related Milestones | CR 07-024 | CAM RESPONSIBLE | CR 08-058 | CR 11-004 | CR 11-006 | CR 11-036 | CR 13-014 | ReBaseline Actuals Adjustment | Planned FinishUDF | CR 07-014 | Milestone Level | CR 07-027 | CR 09-012 | CR 11-026 | CR 12-054 |
| --- | --- | --- | --- | --- | --- | --- | --- | --- | --- | --- | --- | --- | --- | --- | --- | --- | --- | --- | --- | --- | --- | --- | --- | --- | --- | --- | --- | --- | --- | --- | --- |
|  | 1 | **1.2.2.3.6.1 ENGINEERING & DESIGN** |  |  |  |  |  |  |  |  |  |  |  |  |  |  |  |  |  |  |  |  |  |  |  |  |  |  |  |  |  |
|  | 2 | **1.2.2.3.6.2 SUPPORT STRUCTURE** |  |  |  |  |  |  |  |  |  |  |  |  |  |  |  |  |  |  |  |  |  |  |  |  |  |  |  |  |  |
|  | 3 | **1.2.2.3.6.3 SHIELD HOUSE** |  |  |  |  |  |  |  |  |  |  |  |  |  |  |  |  |  |  |  |  |  |  |  |  |  |  |  |  |  |
|  | 4 | **1.2.2.3.6.4 CRYOGENIC SYSTEM** |  |  |  |  |  |  |  |  |  |  |  |  |  |  |  |  |  |  |  |  |  |  |  |  |  |  |  |  |  |
|  | 5 | **1.2.2.3.6.5 VACUUM SYSTEM** |  |  |  |  |  |  |  |  |  |  |  |  |  |  |  |  |  |  |  |  |  |  |  |  |  |  |  |  |  |
|  | 6 | **1.2.2.3.6.6 CABLING** |  |  |  |  |  |  |  |  |  |  |  |  |  |  |  |  |  |  |  |  |  |  |  |  |  |  |  |  |  |
|  | 7 | **1.2.2.3.6.7 SOS PIVOT MODIFICATION** |  |  |  |  |  |  |  |  |  |  |  |  |  |  |  |  |  |  |  |  |  |  |  |  |  |  |  |  |  |
|  | 8 | **1.2.2.3.6.8 INSTALLATION** |  |  |  |  |  |  |  |  |  |  |  |  |  |  |  |  |  |  |  |  |  |  |  |  |  |  |  |  |  |
|  | 3 | **1.2.3 HALL D** |  |  | 2006-10-02 | 2013-08-30 |  |  |  |  |  |  |  |  |  |  |  |  |  |  |  |  |  |  |  |  |  |  |  |  |  |
|  | 1 | **1.2.3.1 SOLENOID** |  |  | 2008-10-01 | 2013-08-30 |  |  |  |  |  |  |  |  |  |  |  |  |  |  |  |  |  |  |  |  |  |  |  |  |  |
| 151009E5 |  | FY09 Travel (SOLENOID) |  | 59d | 2008-10-01 | 2008-12-24 | 9-090M | 431d | 0d |  | TRAVEL | 286.74 | CHUDAKOV | 1 | 1 | D | 07-024 | EUGENE C | 08-058 | 11-004 | 11-006 | 11-036 |  |  |  |  |  |  |  |  |  |
| 1231000 |  | Re-Baseline Actuals Adjustment |  | 1d | 2013-08-30 | 2013-08-30 | 9-130M FS+227d | 20d |  |  | PROCUREMENT>$50K 69 NO ESCALATION | 165.15 | CHUDAKOV | 1 | 1 |  |  | EUGENE C |  |  |  |  | 13-014 | ADJ |  |  |  |  |  |  |  |
|  | 2 | **1.2.3.2 DETECTORS** |  |  | 2006-10-02 | 2013-08-30 |  |  |  |  |  |  |  |  |  |  |  |  |  |  |  |  |  |  |  |  |  |  |  |  |  |
| 123211010 |  | Fall Progress updates including safety assessment at Hall D collaboration meeting |  | 10d | 2006-11-15 | 2006-11-30 | 9-070M FS+32d | 568d | 0d |  |  |  | CHUDAKOV | 1 | 1 | D |  | EUGENE C |  |  |  |  |  |  | 2006-11-30 | 07-014 |  |  |  |  |  |
| 123211010M |  | Fall Design updates based on collaboration assessment | milestone | 0d | 2006-12-15 | 2006-12-15 | 123211010 FS+11d | 568d | 0d |  |  |  | CHUDAKOV | 1 | 1 | D |  | EUGENE C |  |  |  |  |  |  | 2006-12-15 | 07-014 | 6 |  |  |  |  |
| 123211020 |  | Spring Progress updates including safety assessment at Hall D collaboration meeting |  | 10d | 2007-04-30 | 2007-05-11 | 123211010M FS+87d | 568d | 0d |  |  |  | CHUDAKOV | 1 | 1 | D |  | EUGENE C |  |  |  |  |  |  | 2007-05-11 | 07-014 |  |  |  |  |  |
| 123211020M |  | Spring Safety Design Report updates based on collaboration assessment | milestone | 0d | 2007-05-15 | 2007-05-15 | 123211020 FS+2d | 568d | 332d |  |  |  | CHUDAKOV | 1 | 1 | D |  | EUGENE C |  |  |  |  |  |  | 2007-05-15 | 07-014 | 5 |  |  |  |  |
|  | 1 | **1.2.3.2.1 TRACKING** |  |  | 2006-10-02 | 2013-08-30 |  |  |  |  |  |  |  |  |  |  |  |  |  |  |  |  |  |  |  |  |  |  |  |  |  |
| 123211015 |  | Interim Design and Safety Assessment of drift chambers |  | 10d | 2007-03-15 | 2007-03-28 | 9-070M FS+108d, 1152005 FS-100d | 454d | 0d |  |  |  | CHUDAKOV | 1 | 1 | D |  | EUGENE C |  |  |  |  |  |  | 2007-05-22 | 07-014 |  |  |  |  |  |
| 123211015M |  | Interim Drift chamber design requirements updated | milestone | 0d | 2007-04-16 | 2007-04-16 | 123211015 FS+13d | 454d | 116d |  |  |  | CHUDAKOV | 1 | 1 | D |  | EUGENE C |  |  |  |  |  |  | 2007-06-11 | 07-014 | 6 |  |  |  |  |
| 12321017 |  | Final Dsgn & Safty Assessmnt of Drift Chambs |  | 10d | 2008-09-16 | 2008-09-29 | 123211020M, 123213010, 123212035, 123211055 | 236d | 0d |  |  |  | CHUDAKOV | 1 | 1 | D |  | EUGENE C |  |  |  |  |  |  |  |  |  | 07-027 |  |  |  |
| 12321018M |  | Drift Chamb Dsgn Rquirmnts Finalized++ | milestone | 0d | 2008-10-16 | 2008-10-16 | 12321017 FS+13d | 236d | 48d |  |  |  | CHUDAKOV | 1 | 1 | D |  | EUGENE C |  |  |  |  |  |  |  |  | 6 | 07-027 |  |  |  |
|  | 1 | **1.2.3.2.1.1 FORWARD CHAMBERS** |  |  | 2006-10-02 | 2013-08-30 |  |  |  |  |  |  |  |  |  |  |  |  |  |  |  |  |  |  |  |  |  |  |  |  |  |
| 123211005 |  | Develop FDC design (FWD CHAMB) |  | 79d | 2006-10-02 | 2007-02-01 | 9-070M | 339d | 1d |  | MECH TECH [252.2 h]; CONTRB UNIV LBR [461.2 h] | 10,032.51 | CHUDAKOV | 1 | 1 | D |  | EUGENE C |  |  |  |  |  |  | 2007-09-28 | 07-014 |  |  | 09-012 |  |  |
| 12321105A |  | Develop FDC design (FWD CHAMB) |  | 167d | 2007-02-02 | 2007-09-28 | 123211005 | 338d | 0d | start on or after 2007-02-02 | ELEC ENG [298.8 h]; MECH DES [733.2 h] | 50,101.18 | CHUDAKOV | 1 | 1 | D |  | EUGENE C |  |  |  |  |  |  | 2007-09-28 | 07-014 |  |  | 09-012 |  |  |
| 123211025 |  | Specify All FDC Chamb Matrl's |  | 45d | 2007-10-01 | 2007-12-04 | 123211015M, 12321105A | 338d | 0d |  | CONTRB UNIV LBR [400 h] |  | CHUDAKOV | 1 | 1 | D |  | EUGENE C |  |  |  |  |  |  |  |  |  |  |  |  |  |
| 123211030 |  | Detail FDC Final Procedure for Chamb Wire Stringing, Constrctn, & Assy |  | 45d | 2007-10-01 | 2007-12-04 | 12321105A | 338d | 0d |  | CONTRB UNIV LBR [400 h] |  | CHUDAKOV | 1 | 1 | D |  | EUGENE C |  |  |  |  |  |  |  |  |  |  |  |  |  |
| 123211035 |  | Comp FDC Layout & Dsgn of on-board Electrnc's |  | 45d | 2007-10-01 | 2007-12-04 | 12321105A | 338d | 0d |  | MECH TECH [400 h] | 15,680 | CHUDAKOV | 1 | 1 | D |  | EUGENE C |  |  |  |  |  |  |  |  |  |  |  |  |  |
| 123211040 |  | Dsgn FDC Gas Handling Sys |  | 45d | 2007-10-01 | 2007-12-04 | 12321105A | 338d | 0d |  | MECH TECH [400 h] | 15,680 | CHUDAKOV | 1 | 1 | D |  | EUGENE C |  |  |  |  |  |  |  |  |  |  |  |  |  |
| 123211045 |  | Finalize FDC Cable Spec's, Connectors, Routing, & Packing Decisions |  | 45d | 2007-10-01 | 2007-12-04 | 12321105A | 338d | 0d |  | MECH TECH [308 h] | 12,073.6 | CHUDAKOV | 1 | 1 | D |  | EUGENE C |  |  |  |  |  |  |  |  |  |  |  |  |  |
| 123211050 |  | Comp Final FDC Drawings |  | 45d | 2007-12-05 | 2008-02-15 | 123211025, 123211030, 123211040, 123211035, 123211045 | 338d | 0d |  | MECH ENG [880 h]; CONTRB UNIV LBR [520 h] | 54,419.2 | CHUDAKOV | 1 | 1 | D |  | EUGENE C |  |  |  |  |  |  |  |  |  |  |  |  |  |
| 123211055 |  | Detail FDC Final Procedures for Component Quality Control & Acceptance |  | 45d | 2008-02-19 | 2008-04-21 | 123211050 | 338d | 102d |  | CONTRB UNIV LBR [764 h] |  | CHUDAKOV | 1 | 1 | D |  | EUGENE C |  |  |  |  |  |  |  |  |  |  |  |  |  |
| 15211009EX |  | FY09 Travel (FWD Chambers) |  | 59d | 2008-10-01 | 2008-12-24 | 9-090M | 64d | 0d |  | TRAVEL | 306.8 | CHUDAKOV | 1 | 1 | D | 07-024 | EUGENE C | 08-058 |  | 11-006 |  |  |  |  |  |  |  |  | 11-026 | 12-054F |
| 123211060 |  | Re-Baseline Actuals Adjustment |  | 1d | 2013-08-30 | 2013-08-30 | 9-130M FS+227d | 20d |  |  | PROCUREMENT>$50K 69 NO ESCALATION | 170,922.5 | CHUDAKOV | 1 | 1 |  |  | EUGENE C |  |  |  |  | 13-014 | ADJ |  |  |  |  |  |  |  |

| ID | WBS | Activity | Type | Duration | Start | Finish | Predecessors | Total float | Free float | Constraint | Resources | Cost | Planned FinishUDF | RESP - Responsibility | STRT%COMP for CM EVM | FNSH%COMP for CM EVM | CR 07-014 | HALL D Related Milestones | CAM RESPONSIBLE | CR 09-012 | CR 07-027 | CR 08-016 | CR 07-024 | CR 08-058 | CR 11-006 | CR 11-026 | CR 12-054 | CR 13-014 | ReBaseline Actuals Adjustment | Milestone Level | Profile change | 12 GeV 1st level Critical Path | 12 GeV 5th level Critical Path |
| --- | --- | --- | --- | --- | --- | --- | --- | --- | --- | --- | --- | --- | --- | --- | --- | --- | --- | --- | --- | --- | --- | --- | --- | --- | --- | --- | --- | --- | --- | --- | --- | --- | --- |
|  | 2 | **1.2.3.2.1.2 CENTRAL CHAMBERS** |  |  | 2006-10-02 | 2013-08-30 |  |  |  |  |  |  |  |  |  |  |  |  |  |  |  |  |  |  |  |  |  |  |  |  |  |  |  |
| 123212005 |  | Develop Preamp design (CENT CHAMB) |  | 80d | 2006-10-02 | 2007-02-01 | 9-070M | 245d | 0d |  |  |  | 2007-09-28 | CHUDAKOV | 1 | 1 | 07-014 | D | EUGENE C | 09-012 |  |  |  |  |  |  |  |  |  |  |  |  |  |
| 123212005A |  | Develop Preamp design (CENT CHAMB) |  | 225d | 2007-02-02 | 2007-12-21 | 123212005 | 245d | 0d |  | PROCUREMENT<$50K 60 NO ESCALATION FY08 | 51,600 | 2007-09-28 | CHUDAKOV | 1 | 1 | 07-014 | D | EUGENE C | 09-012 | 07-027 | 08-016 |  |  |  |  |  |  |  |  |  |  |  |
| 123212008 |  | Preamp Dsgn |  | 80d | 2008-01-02 | 2008-04-24 | 123212005A | 245d | 9d |  | PROCUREMENT<$50K 60 | 32,804.1 |  | CHUDAKOV | 1 | 1 |  | D | EUGENE C |  | 07-027 |  |  |  |  |  |  |  |  |  |  |  |  |
| 123212010 |  | Specify CDC Chamb Matrl's |  | 80d | 2008-01-02 | 2008-04-24 | 123212005A | 245d | 9d |  | CONTRB UNIV LBR [960 h] |  |  | CHUDAKOV | 1 | 1 |  | D | EUGENE C |  | 07-027 |  |  |  |  |  |  |  |  |  |  |  |  |
| 123212015 |  | Detail CDC Final Procedure for Chamb Tube Mounting,/Wire Stringing,/Constrctn/Assy |  | 80d | 2008-01-02 | 2008-04-24 | 123212005A | 245d | 9d |  | CONTRB UNIV LBR [1480 h] |  |  | CHUDAKOV | 1 | 1 |  | D | EUGENE C |  | 07-027 |  |  |  |  |  |  |  |  |  |  |  |  |
| 123212020 |  | Dsgn CDC Gas Handling Sys |  | 80d | 2008-01-02 | 2008-04-24 | 123212005A | 245d | 9d |  | CONTRB UNIV LBR [1696 h] |  |  | CHUDAKOV | 1 | 1 |  | D | EUGENE C |  | 07-027 |  |  |  |  |  |  |  |  |  |  |  |  |
| 123212025 |  | Finalize CDC Cable Spec's, Connectors, Routing & Packing |  | 80d | 2008-01-02 | 2008-04-24 | 123212005A | 245d | 9d |  | MECH DES [1740 h] | 73,915.2 |  | CHUDAKOV | 1 | 1 |  | D | EUGENE C |  | 07-027 |  |  |  |  |  |  |  |  |  |  |  |  |
| 123212030 |  | Comp CDC Final Drawings |  | 80d | 2008-05-08 | 2008-08-29 | 123212008, 123212015, 123212020, 1152035 FS-100d, 1152030 FS-100d, 123212010, 123212025 | 236d | 0d |  | MECH DES [1740 h] | 73,915.2 |  | CHUDAKOV | 1 | 1 |  | D | EUGENE C |  | 07-027 |  |  |  |  |  |  |  |  |  |  |  |  |
| 123212035 |  | Detail CDC Final Procedures for Component Quality Control & Acceptance |  | 40d | 2008-07-21 | 2008-09-15 | 123212030 FS-30d | 236d | 0d |  | CONTRB UNIV LBR [1760 h] |  |  | CHUDAKOV | 1 | 1 |  | D | EUGENE C |  | 07-027 |  |  |  |  |  |  |  |  |  |  |  |  |
| 15212009EX |  | FY09 Travel (CENT CHAMB) |  | 59d | 2008-10-01 | 2008-12-24 | 9-090M | 119d | 0d |  | TRAVEL | 306.8 |  | CHUDAKOV | 1 | 1 |  | D | EUGENE C |  |  |  | 07-024 | 08-058 | 11-006 | 11-026 | 12-054F |  |  |  |  |  |  |
| 123212040 |  | Re-Baseline Actuals Adjustment |  | 1d | 2013-08-30 | 2013-08-30 | 9-130M FS+227d | 20d |  |  | PROCUREMENT>$50K 69 NO ESCALATION | 36,347.96 |  | CHUDAKOV | 1 | 1 |  |  | EUGENE C |  |  |  |  |  |  |  |  | 13-014 | ADJ |  |  |  |  |
|  | 3 | **1.2.3.2.1.3 START COUNTER** |  |  | 2006-10-02 | 2013-08-30 |  |  |  |  |  |  |  |  |  |  |  |  |  |  |  |  |  |  |  |  |  |  |  |  |  |  |  |
| 123213005LOE |  | Start counter design (START CNTR) |  | 247d | 2006-10-02 | 2007-09-28 | 9-070M | 373d | 0d |  |  |  | 2007-09-28 | CHUDAKOV | 1 | 1 | 07-014 | D | EUGENE C | 09-012 |  |  |  |  |  |  |  |  |  |  |  |  |  |
| 123213010 |  | Evaluate H-B Start Counter Use in H-D 08 |  | 100d | 2007-10-01 | 2008-03-03 | 123213005LOE | 373d | 137d |  | CONTRB UNIV LBR [704 h] |  |  | CHUDAKOV | 1 | 1 |  | D | EUGENE C |  |  |  |  |  |  |  |  |  |  |  |  |  |  |
| 123213015 |  | Re-Baseline Actuals Adjustment |  | 1d | 2013-08-30 | 2013-08-30 | 9-130M FS+227d | 20d |  |  | PROCUREMENT>$50K 69 NO ESCALATION | 224.21 |  | CHUDAKOV | 1 | 1 |  |  | EUGENE C |  |  |  |  |  |  |  |  | 13-014 | ADJ |  |  |  |  |
|  | 2 | **1.2.3.2.2 CALORIMETRY** |  |  | 2006-10-02 | 2013-08-30 |  |  |  |  |  |  |  |  |  |  |  |  |  |  |  |  |  |  |  |  |  |  |  |  |  |  |  |
| 12322017 |  | Final Dsgn & Safty Assessmnt of Calorimeters |  | 10d | 2008-08-01 | 2008-08-14 | 123221804bLOE, 123223010, 123223015, 123222025, 123221025, 123223020, 123222020 FS+20d, 123222030 | 267d | 0d |  |  |  |  | CHUDAKOV | 1 | 1 |  | D | EUGENE C |  | 07-027 |  |  |  |  |  |  |  |  |  |  |  |  |
| 12322018M |  | Calorimeter Dsgn Rquirmnts Finalized++ | milestone | 0d | 2008-09-03 | 2008-09-03 | 12322017 FS+13d | 267d | 60d |  |  |  |  | CHUDAKOV | 1 | 1 |  | D | EUGENE C |  | 07-027 |  |  |  |  |  |  |  |  | 6 | C |  |  |
|  | 1 | **1.2.3.2.2.1 BARREL CALORIMETER** |  |  | 2006-10-02 | 2013-08-30 |  |  |  |  |  |  |  |  |  |  |  |  |  |  |  |  |  |  |  |  |  |  |  |  |  |  |  |
| 123221002 |  | Develop BCAL design (BCAL) |  | 80d | 2006-10-02 | 2007-02-01 | 9-070M | 47d | 0d |  | CONTRB UNIV LBR [755.2 h] |  | 2007-09-28 | CHUDAKOV | 1 | 1 | 07-014 | D | EUGENE C | 09-012 |  |  |  |  |  |  |  |  |  |  |  | 1 | 5 |
| 123221004LOE |  | FY07 BCAL postdoc for design (BCAL) |  | 1d | 2006-10-02 | 2006-10-02 | 9-070M | 709d | 247d |  |  |  | 2007-09-28 | CHUDAKOV | 1 | 1 | 07-014 | D | EUGENE C | 09-012 |  |  |  |  |  |  |  |  |  |  |  |  |  |
| 123221007LOE |  | FY07 Hall D project administration (BCAL) |  | 79d | 2006-10-02 | 2007-02-01 | 9-070M | 59d | 0d |  | SCIENTIST [122.8 h] | 7,882.53 | 2007-09-28 | CHUDAKOV | 1 | 1 | 07-014 | D | EUGENE C | 09-012 | 07-027 |  |  |  |  |  |  |  |  |  |  |  |  |
| 123221000 |  | Assessment of SiPM progress toward use with BCAL |  | 20d | 2007-01-02 | 2007-01-30 | 9-070M FS+58d | 494d | 0d |  |  |  | 2007-01-30 | CHUDAKOV | 1 | 1 | 07-014 | D | EUGENE C |  |  |  |  |  |  |  |  |  |  |  |  |  |  |
| 123221908LOE |  | FY08 H-D Proj Admin (BCAL) |  | 248d | 2007-02-01 | 2008-02-04 | 123221007LOE | 126d |  |  | SCIENTIST [440 h] | 27,467.49 |  | CHUDAKOV | 1 | 1 |  | D | EUGENE C |  | 07-027 |  |  |  |  |  |  |  |  |  |  |  |  |
| 123221002A |  | Develop BCAL design (BCAL) |  | 167d | 2007-02-02 | 2007-09-28 | 123221002 | 47d | 0d |  | MECH ENG [520 h]; MECH DES [1020 h] | 75,578.56 | 2007-09-28 | CHUDAKOV | 1 | 1 | 07-014 | D | EUGENE C | 09-012 | 07-027 |  |  |  |  |  |  |  |  |  |  | 1 | 5 |
| 123221007ALOE |  | FY07 Hall D project administration (BCAL) |  | 167d | 2007-02-02 | 2007-09-28 | 123221007LOE | 58d |  | start on or after 2007-02-02 | SCIENTIST [337.6 h] | 21,096.74 | 2007-09-28 | CHUDAKOV | 1 | 1 | 07-014 | D | EUGENE C | 09-012 |  |  |  |  |  |  |  |  |  |  |  |  |  |
| 123221000M |  | Decision on readout for BCAL | milestone | 0d | 2007-03-01 | 2007-03-01 | 123221000 FS+21d | 494d | 31d |  |  |  | 2007-03-01 | CHUDAKOV | 1 | 1 | 07-014 | D | EUGENE C |  |  |  |  |  |  |  |  |  |  | 6 |  |  |  |
| 123221004 |  | FY07 BCAL postdoc for design (BCAL) |  | 117d | 2007-04-16 | 2007-09-28 | 123221000M, 9-070M FS+130d | 463d | 1d |  | PD UNIV STAFF [1200 h] | 58,742.79 | 2007-09-28 | CHUDAKOV | 1 | 1 | 07-014 | D | EUGENE C |  |  |  |  |  |  |  |  |  |  |  |  |  |  |
| 123221020 |  | Drawings of Supprt in Solenoid (BCAL) |  | 110d | 2007-10-01 | 2008-03-17 | 123221002A | 47d | 5d |  | CONTRB UNIV LBR [1196 h]; PD UNIV STAFF [440 h] | 21,806.4 |  | CHUDAKOV | 1 | 1 |  | D | EUGENE C |  | 07-027 |  |  |  |  |  |  |  |  |  |  | 1 | 5 |
| 123221804bLOE |  | FY08 BCAL postdoc for Dsgn (BCAL) |  | 10d | 2007-10-02 | 2007-10-15 | 1152015LOEA, 9-080M, 123221004LOE, 1152010A, 123221004 | 462d | 195d |  | PD UNIV STAFF [60 h] | 2,973.6 |  | CHUDAKOV | 1 | 1 |  | D | EUGENE C |  |  |  |  |  |  |  |  |  |  |  |  |  |  |
| 123221025 |  | Assy Drawings (BCAL) |  | 91d | 2008-03-25 | 2008-07-31 | 1152040, 123221020 | 42d | 0d |  | CONTRB UNIV LBR [1240 h]; PD UNIV STAFF [364 h]; PROCUREMENT<$50K 60; MECH ENG [648 h] | 107,313.15 |  | CHUDAKOV | 1 | 1 |  | D | EUGENE C |  | 07-027 |  | 07-024 |  |  |  |  |  |  |  |  | 1 | 5 |
| 15221009EX |  | FY09 Travel (BarCal) |  | 59d | 2008-10-01 | 2008-12-24 | 9-090M | 496d | 0d |  | TRAVEL | 1,756.43 |  | CHUDAKOV | 1 | 1 |  | D | EUGENE C |  |  |  | 07-024 | 08-058 | 11-006 | 11-026 |  |  |  |  |  |  |  |
| 123221030 |  | Re-Baseline Actuals Adjustment |  | 1d | 2013-08-30 | 2013-08-30 | 9-130M FS+227d | 20d |  |  | PROCUREMENT>$50K 69 NO ESCALATION | 133,589.16 |  | CHUDAKOV | 1 | 1 |  |  | EUGENE C |  |  |  |  |  |  |  |  | 13-014 | ADJ |  |  |  |  |

Notes:
- 123212005: TEST of New Cat: Move 30K to ACD ask Will
- 123212005A: TEST of New Cat: Move 30K to ACD ask Will

| ID | WBS | Activity | Type | Duration | Start | Finish | Predecessors | Total float | Free float | Resources | Cost | Planned FinishUDF | RESP - Responsibility | STRT%COMP for CM EVM | FNSH%COMP for CM EVM | CR 07-014 | HALL D Related Milestones | CAM RESPONSIBLE | CR 09-012 | CR 07-024 | CR 08-058 | CR 11-006 | CR 11-026 | CR 12-054 | CR 13-014 | ReBaseline Actuals Adjustment | CR 07-027 | Milestone Level |
| --- | --- | --- | --- | --- | --- | --- | --- | --- | --- | --- | --- | --- | --- | --- | --- | --- | --- | --- | --- | --- | --- | --- | --- | --- | --- | --- | --- | --- |
|  | 2 | **1.2.3.2.2.2 FORWARD CALORIMETER** |  |  | 2006-10-02 | 2013-08-30 |  |  |  |  |  |  |  |  |  |  |  |  |  |  |  |  |  |  |  |  |  |  |
| 123222005 |  | Develop FCAL modifications for use in Hall D (FCAL) |  | 247d | 2006-10-02 | 2007-09-28 | 9-070M | 283d | 0d |  |  | 2007-09-28 | CHUDAKOV | 1 | 1 | 07-014 | D | EUGENE C | 09-012 |  |  |  |  |  |  |  |  |  |
| 123222010 |  | Drawings of Glass Supprt to circular geometry (FCAL) |  | 60d | 2007-10-01 | 2008-01-03 | 123222005, 1152025A | 353d | 70d | PROCUREMENT>$50K 69; CONTRB UNIV LBR [480 h]; MECH ENG [880 h] | 109,047.99 |  | CHUDAKOV | 1 | 1 |  | D | EUGENE C |  | 07-024 |  |  |  |  |  |  |  |  |
| 123222015 |  | Drawings of Cellular Wall (FCAL) |  | 130d | 2007-10-01 | 2008-04-14 | 123222005 | 283d | 0d | PROCUREMENT<$50K 60 | 54,628.79 |  | CHUDAKOV | 1 | 1 |  | D | EUGENE C |  |  |  |  |  |  |  |  |  |  |
| 123222025 |  | Drawings for attaching PMTs to Glass (FCAL) |  | 75d | 2007-10-01 | 2008-01-25 | 123222005 | 398d | 131d | CONTRB UNIV LBR [880 h] |  |  | CHUDAKOV | 1 | 1 |  | D | EUGENE C |  |  |  |  |  |  |  |  |  |  |
| 123222030 |  | Drawings for Light Guides (FCAL) |  | 75d | 2007-10-01 | 2008-01-25 | 123222005 | 398d | 131d | PD UNIV STUDNT [880 h] | 8,280.8 |  | CHUDAKOV | 1 | 1 |  | D | EUGENE C |  |  |  |  |  |  |  |  |  |  |
| 123222020 |  | Assy Plans for stacking Glass (FCAL) |  | 40d | 2008-04-15 | 2008-06-10 | 123222010, 123222015, 123222005 | 283d | 16d | CONTRB UNIV LBR [359.88 h]; PD UNIV STUDNT [856.12 h] | 8,056.07 |  | CHUDAKOV | 1 | 1 |  | D | EUGENE C |  |  |  |  |  |  |  |  |  |  |
| 15222009EX |  | FY09 Travel (FWD CAL) |  | 59d | 2008-10-01 | 2008-12-24 | 9-090M | 317d | 0d | TRAVEL | 201.78 |  | CHUDAKOV | 1 | 1 |  | D | EUGENE C |  | 07-024 | 08-058 | 11-006 | 11-026 | 12-054F |  |  |  |  |
| 123222035 |  | Re-Baseline Actuals Adjustment |  | 1d | 2013-08-30 | 2013-08-30 | 9-130M FS+227d | 20d |  | PROCUREMENT>$50K 69 NO ESCALATION | -1,142.37 |  | CHUDAKOV | 1 | 1 |  |  | EUGENE C |  |  |  |  |  |  | 13-014 | ADJ |  |  |
|  | 3 | **1.2.3.2.2.3 UPSTREAM PHOTON VETO** |  |  | 2006-10-02 | 2008-07-09 |  |  |  |  |  |  |  |  |  |  |  |  |  |  |  |  |  |  |  |  |  |  |
| 123223005LOE |  | Develop Upstream Photon Veto Design (CAL TOF) |  | 80d | 2006-10-02 | 2007-02-01 | 9-070M | 283d | 0d | CONTRB UNIV LBR [44.8 h] |  | 2007-09-28 | CHUDAKOV | 1 | 1 | 07-014 | D | EUGENE C |  |  |  |  |  |  |  |  |  |  |
| 123223005ALOE |  | Develop Upstream Photon Veto Design (CAL TOF) |  | 167d | 2007-02-02 | 2007-09-28 | 123223005LOE | 283d | 0d |  |  | 2007-09-28 | CHUDAKOV | 1 | 1 | 07-014 | D | EUGENE C | 09-012 |  |  |  |  |  |  |  |  |  |
| 123223010 |  | Drawings for UPV Frame (CAL TOF) |  | 60d | 2007-10-01 | 2008-01-03 | 123223005ALOE, 1152020 | 353d | 70d | CONTRB UNIV LBR [40 h] |  |  | CHUDAKOV | 1 | 1 |  | D | EUGENE C |  |  |  |  |  |  |  |  |  |  |
| 123223015 |  | Drawings for individual Compnts (CAL TOF) |  | 130d | 2007-10-01 | 2008-04-14 | 123223005ALOE | 283d | 0d | CONTRB UNIV LBR [40 h] |  |  | CHUDAKOV | 1 | 1 |  | D | EUGENE C |  |  |  |  |  |  |  |  |  |  |
| 123223020 |  | Dsgn Supprt Frame & method for maintenance (CAL TOF) |  | 60d | 2008-04-15 | 2008-07-09 | 123223010, 123223015 | 283d | 16d | CONTRB UNIV LBR [80 h] |  |  | CHUDAKOV | 1 | 1 |  | D | EUGENE C |  |  |  |  |  |  |  |  |  |  |
|  | 3 | **1.2.3.2.3 PARTICLE ID** |  |  | 2006-10-02 | 2013-08-30 |  |  |  |  |  |  |  |  |  |  |  |  |  |  |  |  |  |  |  |  |  |  |
| 12323039 |  | Final Dsgn & Safty Assessmnt of Particle ID |  | 10d | 2009-06-04 | 2009-06-17 | 123232010, 123231030, 123232035, 123232015, 123232025, 123232030, 123232020 | 73d | 0d |  |  |  | CHUDAKOV | 1 | 1 |  | D | EUGENE C |  |  |  |  |  |  |  |  | 07-027 |  |
| 12323040M |  | Particle ID Dsgn Rquirmnts Finalized++ | milestone | 0d | 2009-06-17 | 2009-06-17 | 12323039 | 73d |  |  |  |  | CHUDAKOV | 1 | 1 |  | D | EUGENE C |  |  |  |  |  |  |  |  | 07-027 | 6 |
|  | 1 | **1.2.3.2.3.1 TIME OF FLIGHT** |  |  | 2006-10-02 | 2008-09-16 |  |  |  |  |  |  |  |  |  |  |  |  |  |  |  |  |  |  |  |  |  |  |
| 123231005LOE |  | Develop TOF integration (PART ID TOF) |  | 80d | 2006-10-02 | 2007-02-01 | 9-070M | 248d | 0d | CONTRB UNIV LBR [552 h] |  | 2007-09-28 | CHUDAKOV | 1 | 1 | 07-014 | D | EUGENE C |  |  |  |  |  |  |  |  |  |  |
| 123231005ALOE |  | Develop TOF integration (PART ID TOF) |  | 167d | 2007-02-02 | 2007-09-28 | 123231005LOE | 248d | 0d |  |  | 2007-09-28 | CHUDAKOV | 1 | 1 | 07-014 | D | EUGENE C |  |  |  |  |  |  |  |  |  |  |
| 123231010 |  | Drawings of Scintillator Counters (PART ID TOF) |  | 45d | 2007-10-01 | 2007-12-04 | 123231005ALOE | 248d | 0d | CONTRB UNIV LBR [360 h] |  |  | CHUDAKOV | 1 | 1 |  | D | EUGENE C |  |  |  |  |  |  |  |  |  |  |
| 123231015 |  | Drawings of PMT Housing Assy (PART ID TOF) |  | 45d | 2007-12-05 | 2008-02-15 | 123231010 | 248d | 0d | CONTRB UNIV LBR [360 h] |  |  | CHUDAKOV | 1 | 1 |  | D | EUGENE C |  |  |  |  |  |  |  |  |  |  |
| 123231020 |  | Dsgn Voltage Divider for PMT (PART ID TOF) |  | 45d | 2008-02-19 | 2008-04-21 | 123231015 | 248d | 0d | CONTRB UNIV LBR [360 h] |  |  | CHUDAKOV | 1 | 1 |  | D | EUGENE C |  |  |  |  |  |  |  |  |  |  |
| 123231025 |  | Dsgn Signal Splitting Between ADC & Discriminator/TDC (PART ID TOF) |  | 44d | 2008-04-22 | 2008-06-23 | 123231020 | 248d | 0d | CONTRB UNIV LBR [360 h] |  |  | CHUDAKOV | 1 | 1 |  | D | EUGENE C |  |  |  |  |  |  |  |  |  |  |
| 123231030 |  | Dsgn Mounting Frame for Counters (PART ID TOF) |  | 59d | 2008-06-24 | 2008-09-16 | 123231025 | 248d | 175d | CONTRB UNIV LBR [520 h] |  |  | CHUDAKOV | 1 | 1 |  | D | EUGENE C |  |  |  |  |  |  |  |  |  |  |

| ID | WBS | Activity | Type | Duration | Start | Finish | Predecessors | Total float | Free float | Resources | Cost | Planned FinishUDF | RESP - Responsibility | STRT%COMP for CM EVM | FNSH%COMP for CM EVM | CR 07-014 | HALL D Related Milestones | CAM RESPONSIBLE | CR 09-012 | CR 07-027 | CR 07-024 | CR 13-014 | ReBaseline Actuals Adjustment | Milestone Level | ACT BRIDGING FY SPLIT | EXPNS ACT BRIDGING FY SPLIT |
| --- | --- | --- | --- | --- | --- | --- | --- | --- | --- | --- | --- | --- | --- | --- | --- | --- | --- | --- | --- | --- | --- | --- | --- | --- | --- | --- |
|  | 2 | **1.2.3.2.3.2 CERENKOV COUNTER** |  |  | 2006-10-02 | 2013-08-30 |  |  |  |  |  |  |  |  |  |  |  |  |  |  |  |  |  |  |  |  |
| 123232005 |  | Develop CER design (CERENKOV CNTR) |  | 80d | 2006-10-02 | 2007-02-01 | 9-070M | 261d | 0d |  |  | 2007-09-28 | CHUDAKOV | 1 | 1 | 07-014 | D | EUGENE C | 09-012 |  |  |  |  |  |  |  |
| 123232005A |  | Develop CER design (CERENKOV CNTR) |  | 167d | 2007-02-02 | 2007-09-28 | 123232005 | 261d | 188d | SCIENTIST [332 h]; PD UNIV STUDNT [416 h]; VISTNG USERS [600 h] | 34,894.55 | 2007-09-28 | CHUDAKOV | 1 | 1 | 07-014 | D | EUGENE C | 09-012 | 07-027 |  |  |  |  |  |  |
| 123232015 |  | Comp Drawings for Mirrors & Fab (CERENKOV CNTR) |  | 65d | 2009-01-05 | 2009-04-07 | 9-090M FS+60d, 123232005A | 113d | 40d |  |  |  | CHUDAKOV | 1 | 1 |  | D | EUGENE C | 09-012 | 07-027 | 07-024 |  |  |  |  |  |
| 123232025 |  | Develop Matrl Spec's for Gas Windows (CERENKOV CNTR) |  | 20d | 2009-01-05 | 2009-02-02 | 123232005A, 9-090M FS+60d | 158d | 85d |  |  |  | CHUDAKOV | 1 | 1 |  | D | EUGENE C | 09-012 | 07-027 | 07-024 |  |  |  |  |  |
| 123232030 |  | Dsgn Supprt Frame for Cerenkov Detector (CERENKOV CNTR) |  | 65d | 2009-01-05 | 2009-04-07 | 9-090M FS+60d, 123232005A | 113d | 40d |  |  |  | CHUDAKOV | 1 | 1 |  | D | EUGENE C | 09-012 | 07-027 | 07-024 |  |  |  |  |  |
| 123232035 |  | Dsgn Alignment Procedure for Mirrors (CERENKOV CNTR) |  | 65d | 2009-01-05 | 2009-04-07 | 123232005A, 9-090M FS+60d | 113d | 40d |  |  |  | CHUDAKOV | 1 | 1 |  | D | EUGENE C | 09-012 | 07-027 | 07-024 |  |  |  |  |  |
| 123232010 |  | Comp Spec's for Mirrors (CERENKOV CNTR) |  | 45d | 2009-04-01 | 2009-06-03 | 1152025A, 9-090M FS+120d, 123232005A | 73d | 0d |  |  |  | CHUDAKOV | 1 | 1 |  | D | EUGENE C | 09-012 | 07-027 | 07-024 |  |  |  |  |  |
| 123232020 |  | Drawings for PMT Assy (CERENKOV CNTR) |  | 45d | 2009-04-01 | 2009-06-03 | 123232005A FS+180d, 9-090M FS+120d | 73d | 0d |  |  |  | CHUDAKOV | 1 | 1 |  | D | EUGENE C | 09-012 | 07-027 | 07-024 |  |  |  |  |  |
| 123232040 |  | Re-Baseline Actuals Adjustment |  | 1d | 2013-08-30 | 2013-08-30 | 9-130M FS+227d | 20d |  | PROCUREMENT>$50K 69 NO ESCALATION | -12,101.94 |  | CHUDAKOV | 1 | 1 |  |  | EUGENE C |  |  |  | 13-014 | ADJ |  |  |  |
|  | 3 | **1.2.3.3 COMPUTING** |  |  | 2006-10-02 | 2013-08-30 |  |  |  |  |  |  |  |  |  |  |  |  |  |  |  |  |  |  |  |  |
| 1233039 |  | Final Dsgn & Safty Assessmnt of Computing |  | 10d | 2009-03-20 | 2009-04-02 | 12333020, 12332015, 12331010, 12333015a, 12332025a | 126d | 0d |  |  |  | CHUDAKOV | 1 | 1 |  | D | EUGENE C |  | 07-027 |  |  |  |  |  |  |
| 1233040M |  | Computing Dsgn Rquirmnts Finalized++ | milestone | 0d | 2009-04-02 | 2009-04-02 | 1233039 | 126d |  |  |  |  | CHUDAKOV | 1 | 1 |  | D | EUGENE C |  | 07-027 |  |  |  | 6 |  |  |
|  | 1 | **1.2.3.3.1 DAQ** |  |  | 2006-10-02 | 2013-08-30 |  |  |  |  |  |  |  |  |  |  |  |  |  |  |  |  |  |  |  |  |
| 12331005 |  | Procure architechture and high speed links (DAQ) |  | 247d | 2006-10-02 | 2007-09-28 | 9-070M | 246d | 0d | PROCUREMENT<$50K 60 | 20,640 | 2007-09-28 | CHUDAKOV | 1 | 1 | 07-014 | D | EUGENE C |  | 07-027 |  |  |  |  |  |  |
| 12331010 |  | Proto parallel Event builder (DAQ) (IPL) |  | 130d | 2008-03-18 | 2008-09-18 | 12331005 FS+110d | 246d | 120d | PROCUREMENT<$50K 60 | 43,659.69 |  | CHUDAKOV | 1 | 1 |  | D | EUGENE C |  | 07-027 |  |  |  |  |  |  |
| 12331015 |  | Re-Baseline Actuals Adjustment |  | 1d | 2013-08-30 | 2013-08-30 | 9-130M FS+227d | 20d |  | PROCUREMENT>$50K 69 NO ESCALATION | 13,201.48 |  | CHUDAKOV | 1 | 1 |  |  | EUGENE C |  |  |  | 13-014 | ADJ |  |  |  |
|  | 2 | **1.2.3.3.2 ONLINE COMPUTING** |  |  | 2006-10-02 | 2013-08-30 |  |  |  |  |  |  |  |  |  |  |  |  |  |  |  |  |  |  |  |  |
| 12332005LOE |  | Conduct planning for online system (ONLINE COMP) |  | 80d | 2006-10-02 | 2007-02-01 | 9-070M | 186d | 0d | CONTRB UNIV LBR [101.2 h] |  | 2007-09-28 | CHUDAKOV | 1 | 1 | 07-014 | D | EUGENE C |  |  |  |  |  |  |  |  |
| 12332005ALOE |  | Conduct planning for online system (ONLINE COMP) |  | 167d | 2007-02-02 | 2007-09-28 | 12332005LOE | 186d | 60d |  |  | 2007-09-28 | CHUDAKOV | 1 | 1 | 07-014 | D | EUGENE C | 09-012 |  |  |  |  |  |  |  |
| 12332020 |  | Dsgn Experiment Controls Sys (ONLINE COMP) |  | 170d | 2008-01-04 | 2008-09-04 | 9-080M FS+60d, 12332005ALOE | 126d | 0d | SCIENTIST [920 h] | 57,288.4 |  | CHUDAKOV | 1 | 1 |  | D | EUGENE C |  | 07-027 | 07-024 |  |  |  |  |  |
| 12332010 |  | Dsgn Monitoring Sys (ONLINE COMP) |  | 65d | 2008-04-01 | 2008-07-01 | 9-080M FS+120d, 12332005ALOE | 251d | 0d | SCIENTIST [80 h] | 4,981.6 |  | CHUDAKOV | 1 | 1 |  | D | EUGENE C |  | 07-027 | 07-024 |  |  |  |  |  |
| 12332015 |  | Dsgn Alarm Sys (ONLINE COMP) |  | 50d | 2008-07-02 | 2008-09-11 | 12332010 | 251d | 125d | SCIENTIST [408 h]; PROCUREMENT<$50K 60 | 38,500.97 |  | CHUDAKOV | 1 | 1 |  | D | EUGENE C |  |  | 07-024 |  |  |  |  |  |
| 12332025 |  | FY08 Exp Dsgn Event Display (ONLINE COMP) |  | 18d | 2008-09-05 | 2008-09-30 | 12332020 | 126d | 0d | CONTRB UNIV LBR [49.85 h]; SCIENTIST [105.23 h] | 6,552.67 |  | CHUDAKOV | 1 | 1 |  | D | EUGENE C |  |  | 07-024 |  |  |  | FY08-09 | EXP0809 |
| 12332025a |  | FY09 Exp Dsgn Event Display (ONLINE COMP) |  | 112d | 2008-10-01 | 2009-03-19 | 12332025 | 126d | 0d | CONTRB UNIV LBR [310.15 h]; SCIENTIST [654.77 h] | 42,075.52 |  | CHUDAKOV | 1 | 1 |  | D | EUGENE C |  |  | 07-024 |  |  |  | FY08-09 | EXP0809 |
| 12332030 |  | Re-Baseline Actuals Adjustment |  | 1d | 2013-08-30 | 2013-08-30 | 9-130M FS+227d | 20d |  | PROCUREMENT>$50K 69 NO ESCALATION | -24,281.09 |  | CHUDAKOV | 1 | 1 |  |  | EUGENE C |  |  |  | 13-014 | ADJ |  |  |  |

| ID | WBS | Activity | Type | Duration | Start | Finish | Predecessors | Total float | Free float | Resources | Cost | Planned FinishUDF | RESP - Responsibility | STRT%COMP for CM EVM | FNSH%COMP for CM EVM | CR 07-014 | HALL D Related Milestones | CAM RESPONSIBLE | CR 07-027 | ACT BRIDGING FY SPLIT | EXPNS ACT BRIDGING FY SPLIT | CR 13-014 | ReBaseline Actuals Adjustment | CR 07-002 | CR 09-012 | CR 08-016 | CR 07-024 | CR 08-058 | CR 11-006 | CR 11-026 | CR 11-029 | Milestone Level |
| --- | --- | --- | --- | --- | --- | --- | --- | --- | --- | --- | --- | --- | --- | --- | --- | --- | --- | --- | --- | --- | --- | --- | --- | --- | --- | --- | --- | --- | --- | --- | --- | --- |
|  | 3 | **1.2.3.3.3 OFFLINE COMPUTING** |  |  | 2006-10-02 | 2013-08-30 |  |  |  |  |  |  |  |  |  |  |  |  |  |  |  |  |  |  |  |  |  |  |  |  |  |  |
| 12333005LOE |  | Conduct planning for offline computing (OFFLINE COMP) |  | 80d | 2006-10-02 | 2007-02-01 | 9-070M | 155d | 0d | CONTRB UNIV LBR [202.8 h] |  | 2007-09-28 | CHUDAKOV | 1 | 1 | 07-014 | D | EUGENE C |  |  |  |  |  |  |  |  |  |  |  |  |  |  |
| 12333005ALOE |  | Conduct planning for offline computing (OFFLINE COMP) |  | 167d | 2007-02-02 | 2007-09-28 | 12333005LOE | 155d | 0d |  |  | 2007-09-28 | CHUDAKOV | 1 | 1 | 07-014 | D | EUGENE C |  |  |  |  |  |  |  |  |  |  |  |  |  |  |
| 12333010 |  | Dsgn Reconstruction Framework (OFFLINE COMP) |  | 130d | 2007-10-01 | 2008-04-14 | 12333005ALOE | 155d | 0d | CONTRB UNIV LBR [2204 h]; SCIENTIST [1300 h] | 80,951 |  | CHUDAKOV | 1 | 1 |  | D | EUGENE C | 07-027 |  |  |  |  |  |  |  |  |  |  |  |  |  |
| 12333015 |  | FY08 Exp Dsgn Calibration Databases (OFFLINE COMP) |  | 47d | 2008-07-25 | 2008-09-30 | 12333010 FS+71d | 155d | 0d | SCIENTIST [477.23 h]; CONTRB UNIV LBR [361.54 h] | 29,717.11 |  | CHUDAKOV | 1 | 1 |  | D | EUGENE C | 07-027 | FY08-09 | EXP0809 |  |  |  |  |  |  |  |  |  |  |  |
| 12333020 |  | Dsgn Interface Between Analysis Framework & Simulation (OFFLINE COMP) |  | 130d | 2008-07-25 | 2009-02-05 | 12333010 FS+71d | 155d | 29d | CONTRB UNIV LBR [1000 h] |  |  | CHUDAKOV | 1 | 1 |  | D | EUGENE C | 07-027 | FY08-09 |  |  |  |  |  |  |  |  |  |  |  |  |
| 12333015a |  | FY09 Exp Dsgn Calibration Databases (OFFLINE COMP) |  | 83d | 2008-10-01 | 2009-02-05 | 12333015 | 155d | 29d | CONTRB UNIV LBR [638.46 h]; SCIENTIST [842.77 h] | 54,156.4 |  | CHUDAKOV | 1 | 1 |  | D | EUGENE C | 07-027 | FY08-09 | EXP0809 |  |  |  |  |  |  |  |  |  |  |  |
| 12333025 |  | Re-Baseline Actuals Adjustment |  | 1d | 2013-08-30 | 2013-08-30 | 9-130M FS+227d | 20d |  | PROCUREMENT>$50K 69 NO ESCALATION | 26,474.66 |  | CHUDAKOV | 1 | 1 |  |  | EUGENE C |  |  |  | 13-014 | ADJ |  |  |  |  |  |  |  |  |  |
|  | 4 | **1.2.3.4 ELECTRONICS** |  |  | 2006-10-02 | 2013-08-30 |  |  |  |  |  |  |  |  |  |  |  |  |  |  |  |  |  |  |  |  |  |  |  |  |  |  |
| 12341005 |  | Conduct FADC development (FADC) |  | 79d | 2006-10-02 | 2007-02-01 | 9-070M | 114d | 0d | PROCUREMENT<$50K 60; CONTRB UNIV LBR [541.2 h] | 1,032 | 2007-09-28 | CHUDAKOV | 1 | 1 | 07-014 | D | EUGENE C |  |  |  |  |  | 07-002 | 09-012 |  |  |  |  |  |  |  |
| 12342005 |  | Develop DAQ trigger and electronics integration (TDC) |  | 79d | 2006-10-02 | 2007-02-01 | 9-070M | 199d | 0d |  |  | 2007-09-28 | CHUDAKOV | 1 | 1 | 07-014 | D | EUGENE C |  |  |  |  |  | 07-002 | 09-012 |  |  |  |  |  |  |  |
| 12342010 |  | Develop clock distribution and synchronization (TDC) (IPL) |  | 79d | 2006-10-02 | 2007-02-01 | 9-070M | 114d | 0d | ELEC DES [86.4 h] | 3,886.27 | 2007-09-28 | CHUDAKOV | 1 | 1 | 07-014 | D | EUGENE C |  |  |  |  |  | 07-002 |  |  |  |  |  |  |  |  |
| 12343005 |  | Develop plans for trigger integration (TRGR) |  | 79d | 2006-10-02 | 2007-02-01 | 9-070M | 114d | 0d | CONTRB UNIV LBR [114 h] |  | 2007-09-28 | CHUDAKOV | 1 | 1 | 07-014 | D | EUGENE C |  |  |  |  |  | 07-002 | 09-012 |  |  |  |  |  |  |  |
| 12345005 |  | Integrate electronics subsystems (HV) |  | 79d | 2006-10-02 | 2007-02-01 | 9-070M | 454d | 0d | CONTRB UNIV LBR [40.4 h] |  | 2007-09-28 | CHUDAKOV | 1 | 1 | 07-014 | D | EUGENE C |  |  |  |  |  | 07-002 |  |  |  |  |  |  |  |  |
| 12341005A |  | Conduct FADC development (FADC) |  | 167d | 2007-02-01 | 2007-09-28 | 12341005 | 114d | 1d | ELEC ENG [421.2 h]; PROCUREMENT<$50K 60 | 45,899.25 | 2007-09-28 | CHUDAKOV | 1 | 1 | 07-014 | D | EUGENE C |  |  |  |  |  | 07-002 | 09-012 |  |  |  |  |  |  |  |
| 12342005A |  | Develop DAQ trigger and electronics integration (TDC) |  | 167d | 2007-02-01 | 2007-09-28 | 12342005 | 199d | 86d |  |  | 2007-09-28 | CHUDAKOV | 1 | 1 | 07-014 | D | EUGENE C |  |  |  |  |  | 07-002 | 09-012 |  |  |  |  |  |  |  |
| 12342010A |  | Develop clock distribution and synchronization (TDC) |  | 167d | 2007-02-01 | 2007-09-28 | 12342010 | 114d | 1d |  |  | 2007-09-28 | CHUDAKOV | 1 | 1 | 07-014 | D | EUGENE C |  |  |  |  |  | 07-002 | 09-012 |  |  |  |  |  |  |  |
| 12343005A |  | Develop plans for trigger integration (TRGR) |  | 167d | 2007-02-01 | 2007-09-28 | 12343005 | 114d | 1d |  |  | 2007-09-28 | CHUDAKOV | 1 | 1 | 07-014 | D | EUGENE C |  |  |  |  |  | 07-002 | 09-012 |  |  |  |  |  |  |  |
| 12345005A |  | Integrate electronics subsystems (HV) |  | 167d | 2007-02-01 | 2007-09-28 | 12345005 | 454d | 249d |  |  | 2007-09-28 | CHUDAKOV | 1 | 1 | 07-014 | D | EUGENE C |  |  |  |  |  | 07-002 |  |  |  |  |  |  |  |  |
| 1234050 |  | TDC Version II: Dsgn & Proto (Electrnc's) |  | 40d | 2007-10-01 | 2007-11-27 | 12342005A FS-85d, 12343005A, 12341005A, 12342010A, 1154005A | 113d | 0d | CONTRB UNIV LBR [560 h] |  |  | CHUDAKOV | 1 | 1 |  | D | EUGENE C | 07-027 |  |  |  |  |  |  |  |  |  |  |  |  |  |
| 1234055 |  | TDC Version II: Test, Evaluate (Electrnc's) |  | 40d | 2007-11-28 | 2008-02-01 | 1234050 | 113d | 0d | SCIENTIST [200 h] | 12,454 |  | CHUDAKOV | 1 | 1 |  | D | EUGENE C | 07-027 |  |  |  |  |  |  |  |  |  |  |  |  |  |
| 1234060 |  | Dsgn Clock Distrbtn for TDC Sys (Electrnc's) |  | 60d | 2008-02-04 | 2008-04-28 | 1234055 | 113d | 0d | ELEC DES [440 h] | 19,602 |  | CHUDAKOV | 1 | 1 |  | D | EUGENE C | 07-027 |  |  |  |  |  |  |  |  |  |  |  |  |  |
| 1234065 |  | Dsgn Cabling & Layout for TDC Sys (Electrnc's) (IPL) |  | 30d | 2008-04-29 | 2008-06-10 | 1234060 | 113d | 0d | ELEC TECH [880 h] | 34,258.4 |  | CHUDAKOV | 1 | 1 |  | D | EUGENE C | 07-027 |  |  |  |  |  |  |  |  |  |  |  |  |  |
| 1234070 |  | Dsgn Energy Sum collections into Trigger (Electrnc's) |  | 30d | 2008-06-11 | 2008-07-23 | 1234065 | 113d | 0d | ELEC DES [440 h] | 19,602 |  | CHUDAKOV | 1 | 1 |  | D | EUGENE C | 07-027 |  |  |  |  |  |  |  |  |  |  |  |  |  |
| 1234075 |  | Dsgn Track Count Collection into Trigger (Electrnc's) (IPL) |  | 30d | 2008-07-24 | 2008-09-04 | 1234070 | 113d | 0d | CONTRB UNIV LBR [1320 h] |  |  | CHUDAKOV | 1 | 1 |  | D | EUGENE C | 07-027 |  |  |  |  |  |  |  |  |  |  |  |  |  |
| 1234090 |  | Dsgn Layout of Crates on Detector & Racks (Electrnc's) |  | 18d | 2008-09-05 | 2008-09-30 | 1234075 | 155d | 0d | CONTRB UNIV LBR [1240 h] |  |  | CHUDAKOV | 1 | 1 |  | D | EUGENE C | 07-027 |  |  |  |  |  |  |  |  |  |  |  |  |  |
| 1234080 |  | PROC Dsgn Master Trigger (Electrnc's) |  | 130d | 2008-09-26 | 2009-04-09 | 1154040, 1234075 | 98d | 13d | PROCUREMENT<$50K 60 NO ESCALATION FY09 | 56,444.93 |  | CHUDAKOV | 1 | 1 |  | D | EUGENE C | 07-027 | FY08-09 | EXP0809 |  |  |  | 09-012 | 08-016 |  |  |  |  |  |  |
| 1234080a |  | FY08 Exp Dsgn Master Trigger (Electrnc's) |  | 3d | 2008-09-26 | 2008-09-30 | 1234075, 1154040 | 98d | 0d | SCIENTIST [21.23 h] | 1,321.99 |  | CHUDAKOV | 1 | 1 |  | D | EUGENE C | 07-027 | FY08-09 | EXP0809 |  |  |  | 09-012 | 08-016 |  |  |  |  |  |  |
| 1234115 |  | FY08 Exp Specify Discriminators & Logic for DAQ/Trigger Integration (Electrnc's) |  | 3d | 2008-09-26 | 2008-09-30 | 1154060 | 208d | 0d | ELEC ENG [24 h] | 1,493.76 |  | CHUDAKOV | 1 | 1 |  | D | EUGENE C |  | FY08-09 | EXP0809 |  |  |  | 09-012 |  | 07-024 |  |  |  |  |  |
| 1234030 |  | Dsgn Energy Sum Board (Electrnc's) (IPL) |  | 30d | 2008-10-01 | 2008-11-11 | 1154045, 9-090M | 85d | 0d | PROCUREMENT<$50K 60; ELEC ENG [1668 h]; ELEC DES [480 h] | 145,689.42 |  | CHUDAKOV | 1 | 1 |  | D | EUGENE C | 07-027 |  |  |  |  |  |  |  |  |  |  |  |  |  |
| 1234080b |  | FY09 Exp Dsgn Master Trigger (Electrnc's) |  | 127d | 2008-10-01 | 2009-04-09 | 1234080a | 98d | 13d | SCIENTIST [898.77 h] | 57,754.96 |  | CHUDAKOV | 1 | 1 |  | D | EUGENE C | 07-027 | FY08-09 | EXP0809 |  |  |  | 09-012 | 08-016 |  |  |  |  |  |  |
| 1234085 |  | Specification of Crates Backplane, Pwr Supply, remote sensing (Electrnc's) |  | 20d | 2008-10-01 | 2008-10-28 | 9-090M, 12345005A, 1154010A | 205d | 120d | CONTRB UNIV LBR [1320 h] |  |  | CHUDAKOV | 1 | 1 |  | D | EUGENE C | 07-027 |  |  |  |  |  |  |  |  |  |  |  |  |  |
| 1234095 |  | Dsgn Grounding Scheme of Crates & Racks (Electrnc's) |  | 20d | 2008-10-01 | 2008-10-28 | 1234090 | 155d | 0d | ELEC ENG [200 h] | 12,846 |  | CHUDAKOV | 1 | 1 |  | D | EUGENE C |  |  |  |  |  |  | 09-012 |  | 07-024 |  |  |  |  |  |
| 1234110 |  | Specify HV & Low Voltage Supplies (Electrnc's) |  | 10d | 2008-10-01 | 2008-10-14 | 9-090M, 1154055 | 215d | 130d | ELEC ENG [400 h] | 25,692 |  | CHUDAKOV | 1 | 1 |  | D | EUGENE C | 07-027 | FY08-09 |  |  |  |  | 09-012 |  | 07-024 |  |  |  |  |  |
| 1234115a |  | FY09 Exp Specify Discriminators & Logic for DAQ/Trigger Integration (Electrnc's) |  | 17d | 2008-10-01 | 2008-10-23 | 1154060, 1234115 | 208d | 123d | ELEC ENG [136 h] | 8,735.28 |  | CHUDAKOV | 1 | 1 |  | D | EUGENE C |  | FY08-09 | EXP0809 |  |  |  | 09-012 |  | 07-024 |  |  |  |  |  |
| 1545009EX |  | FY09 Travel (LOGIC, HV) |  | 59d | 2008-10-01 | 2008-12-24 | 9-090M | 310d | 0d | TRAVEL | 303.85 |  | CHUDAKOV | 1 | 1 |  | D | EUGENE C | 07-027 |  |  |  |  |  |  |  | 07-024 | 08-058 | 11-006 | 11-026 | 11-029 |  |
| 1234100 |  | Dsgn networking of Crates (Electrnc's) |  | 20d | 2008-10-29 | 2008-11-25 | 1234095 | 155d | 0d | ELEC ENG [320 h] | 20,553.6 |  | CHUDAKOV | 1 | 1 |  | D | EUGENE C |  |  |  |  |  |  | 09-012 |  | 07-024 |  |  |  |  |  |
| 1234035 |  | Dsgn Crate Clock Distrbtn for FADCs (Electrnc's) |  | 40d | 2008-11-12 | 2009-01-16 | 1154050, 1234030 | 85d | 0d | ELEC DES [400 h] | 18,392 |  | CHUDAKOV | 1 | 1 |  | D | EUGENE C | 07-027 |  |  |  |  |  |  |  |  |  |  |  |  |  |
| 1234105 |  | Dsgn Global Signal Distrbtn Interface to FADCs & TDCs (Electrnc's) |  | 30d | 2008-11-26 | 2009-01-16 | 1234100 | 155d | 70d | ELEC ENG [320 h] | 20,553.6 |  | CHUDAKOV | 1 | 1 |  | D | EUGENE C |  |  |  |  |  |  | 09-012 |  | 07-024 |  |  |  |  |  |
| 1234040 |  | Dsgn Cabling & Layout for FADCs (Electrnc's) |  | 30d | 2009-01-20 | 2009-03-03 | 1234035 | 85d | 0d | ELEC TECH [880 h] | 35,349.6 |  | CHUDAKOV | 1 | 1 |  | D | EUGENE C | 07-027 |  |  |  |  |  |  |  |  |  |  |  |  |  |
| 1234045 |  | Programing of FADCs for Testing (Electrnc's) |  | 40d | 2009-03-04 | 2009-04-28 | 1234040 | 85d | 0d | SCIENTIST [200 h] | 12,852 |  | CHUDAKOV | 1 | 1 |  | D | EUGENE C | 07-027 | FY08-09 |  |  |  |  |  |  |  |  |  |  |  |  |
| 1234159 |  | Final Dsgn & Safty Assessmnt of Electrnc's |  | 10d | 2009-04-29 | 2009-05-12 | 1234075, 1234040, 1234110, 1234080b, 1234045, 1234105, 1234080, 1234085, 1234115a | 85d | 0d |  |  |  | CHUDAKOV | 1 | 1 |  | D | EUGENE C |  |  |  |  |  |  |  |  |  |  |  |  |  |  |
| 1234180M |  | Electrnc's Dsgn Rquirmnts Finalized++ | milestone | 0d | 2009-06-01 | 2009-06-01 | 1234159 FS+13d | 85d |  |  |  |  | CHUDAKOV | 1 | 1 |  | D | EUGENE C | 07-027 |  |  |  |  |  |  |  |  |  |  |  |  | 6 |
| 12345010 |  | Re-Baseline Actuals Adjustment |  | 1d | 2013-08-30 | 2013-08-30 | 9-130M FS+227d | 20d |  | PROCUREMENT>$50K 69 NO ESCALATION | 80,956.11 |  | CHUDAKOV | 1 | 1 |  |  | EUGENE C |  |  |  | 13-014 | ADJ |  |  |  |  |  |  |  |  |  |

Notes:
- 12342010: TEST of New Cat: Remove $20K worth of Elect Designers / time. ask will
- 12342010A: TEST of New Cat: Remove $20K worth of Elect Designers / time. ask will

| ID | WBS | Activity | Type | Duration | Start | Finish | Predecessors | Total float | Free float | Constraint | Resources | Cost | RESP - Responsibility | STRT%COMP for CM EVM | FNSH%COMP for CM EVM | HALL D Related Milestones | CR 07-027 | CAM RESPONSIBLE | Milestone Level | Planned FinishUDF | CR 07-014 | CR 09-012 | ACT BRIDGING FY SPLIT | CR 08-016 | EXPNS ACT BRIDGING FY SPLIT | CR 13-014 | ReBaseline Actuals Adjustment |
| --- | --- | --- | --- | --- | --- | --- | --- | --- | --- | --- | --- | --- | --- | --- | --- | --- | --- | --- | --- | --- | --- | --- | --- | --- | --- | --- | --- |
|  | 1 | **1.2.3.4.1 FADC** |  |  |  |  |  |  |  |  |  |  |  |  |  |  |  |  |  |  |  |  |  |  |  |  |  |
|  | 2 | **1.2.3.4.2 TDC** |  |  |  |  |  |  |  |  |  |  |  |  |  |  |  |  |  |  |  |  |  |  |  |  |  |
|  | 3 | **1.2.3.4.3 TRIGGER** |  |  |  |  |  |  |  |  |  |  |  |  |  |  |  |  |  |  |  |  |  |  |  |  |  |
|  | 4 | **1.2.3.4.4 CRATES** |  |  |  |  |  |  |  |  |  |  |  |  |  |  |  |  |  |  |  |  |  |  |  |  |  |
|  | 5 | **1.2.3.4.5 HV** |  |  |  |  |  |  |  |  |  |  |  |  |  |  |  |  |  |  |  |  |  |  |  |  |  |
|  | 5 | **1.2.3.5 BEAMLINE** |  |  | 2006-10-02 | 2013-08-30 |  |  |  |  |  |  |  |  |  |  |  |  |  |  |  |  |  |  |  |  |  |
|  | 1 | **1.2.3.5.1 TAGGER** |  |  | 2006-10-02 | 2013-08-30 |  |  |  |  |  |  |  |  |  |  |  |  |  |  |  |  |  |  |  |  |  |
| 12351054 |  | Final Dsgn & Safty Assessmnt of Tagger |  | 10d | 2009-03-20 | 2009-04-02 | 123511050, 123512050, 123511045, 123511050b | 113d | 0d |  |  |  | CHUDAKOV | 1 | 1 | D | 07-027 | EUGENE C |  |  |  |  |  |  |  |  |  |
| 12351055M |  | Tagger Dsgn Rquirmnts Finalized++ | milestone | 0d | 2009-04-21 | 2009-04-21 | 12351054 FS+13d | 113d |  |  |  |  | CHUDAKOV | 1 | 1 | D | 07-027 | EUGENE C | 6 |  |  |  |  |  |  |  |  |
|  | 1 | **1.2.3.5.1.1 TAGGING MAGNET** |  |  | 2006-10-02 | 2013-08-30 |  |  |  |  |  |  |  |  |  |  |  |  |  |  |  |  |  |  |  |  |  |
| 123511005 |  | Develop design and procurement strategies (TAGMAG) |  | 247d | 2006-10-02 | 2007-09-28 | 9-070M | 188d | 0d |  |  |  | CHUDAKOV | 1 | 1 | D |  | EUGENE C |  | 2007-09-28 | 07-014 | 09-012 |  |  |  |  |  |
| 123511005LOE |  | Develop design and procurement strategies (TAGMAG) |  | 79d | 2006-10-02 | 2007-02-01 | 9-070M | 189d | 1d |  | CONTRB UNIV LBR [101.6 h]; PD UNIV STAFF [489.6 h] | 24,494.68 | CHUDAKOV | 1 | 1 | D |  | EUGENE C |  | 2007-09-28 | 07-014 |  |  |  |  |  |  |
| 123511005ALOE |  | Develop design and procurement strategies (TAGMAG) |  | 167d | 2007-02-02 | 2007-09-28 | 123511005LOE | 188d | 0d | start on or after 2007-02-02 | PD UNIV STAFF [830.4 h] | 40,917.94 | CHUDAKOV | 1 | 1 | D | 07-027 | EUGENE C |  | 2007-09-28 | 07-014 | 09-012 |  |  |  |  |  |
| 123511010 |  | Top Level Drawings of Quad, Two Dipoles & Vac Sys (TAG MAG) |  | 45d | 2007-04-11 | 2007-06-13 | 123511005 FS-120d, 123511005ALOE FS-120d | 188d | 0d |  | CONTRB UNIV LBR [300 h]; VISTNG USERS [160 h] | 2,753.6 | CHUDAKOV | 1 | 1 | D | 07-027 | EUGENE C |  |  |  |  |  |  |  |  |  |
| 123511015 |  | Vertical Section through a Dipole Showing how Poleshoes & Yoke (TAG MAG) |  | 45d | 2007-06-14 | 2007-08-16 | 123511010 | 188d | 0d |  | VISTNG USERS [160 h]; PD UNIV STAFF [440 h] | 24,039.79 | CHUDAKOV | 1 | 1 | D | 07-027 | EUGENE C |  |  |  |  |  |  |  |  |  |
| 123511020 |  | Top view of a Dipole Showing bolt locations (TAG MAG) |  | 45d | 2007-08-17 | 2007-10-19 | 123511015 | 188d | 0d |  | VISTNG USERS [160 h]; PD UNIV STAFF [440 h] | 24,027.89 | CHUDAKOV | 1 | 1 | D | 07-027 | EUGENE C |  |  |  |  |  |  |  |  |  |
| 123511025 |  | Individual Drawings for Poleshoes (TAG MAG) |  | 45d | 2007-10-22 | 2008-01-03 | 123511020 | 188d | 0d |  | PD UNIV STAFF [440 h]; VISTNG USERS [160 h] | 24,532.8 | CHUDAKOV | 1 | 1 | D | 07-027 | EUGENE C |  |  |  |  |  |  |  |  |  |
| 123511030 |  | Drawings Showing All Different Types of Brackets (TAG MAG) |  | 45d | 2008-01-04 | 2008-03-10 | 123511025 | 188d | 0d |  | PD UNIV STAFF [440 h]; VISTNG USERS [160 h] | 24,532.8 | CHUDAKOV | 1 | 1 | D | 07-027 | EUGENE C |  |  |  |  |  |  |  |  |  |
| 123511035 |  | Layout of Vac Chamb (TAG MAG) |  | 45d | 2008-03-11 | 2008-05-12 | 123511030 | 188d | 0d |  | VISTNG USERS [160 h]; PD UNIV STAFF [440 h] | 24,532.8 | CHUDAKOV | 1 | 1 | D | 07-027 | EUGENE C |  |  |  |  | FY08-09 |  |  |  |  |
| 123511040 |  | Drawings of Top & Bottom Lids, & Back-Wall of Vac Chamb (TAG MAG) |  | 45d | 2008-05-13 | 2008-07-16 | 123511035 | 188d | 0d |  | VISTNG USERS [160 h]; PD UNIV STAFF [440 h] | 24,532.8 | CHUDAKOV | 1 | 1 | D | 07-027 | EUGENE C |  |  |  |  |  |  |  |  |  |
| 123511045 |  | Drawings Showing Assy & Dis-assy of Mag (TAG MAG) |  | 45d | 2008-07-17 | 2008-09-18 | 123511040 | 188d | 0d |  | VISTNG USERS [440 h]; PROCUREMENT<$50K 60 | 35,503.37 | CHUDAKOV | 1 | 1 | D | 07-027 | EUGENE C |  |  |  |  |  |  |  |  |  |
| 123511050 |  | PROC Production of Drawings for Strong Back Supprt for Dipole Magnets. (TAG MAG) |  | 45d | 2008-09-19 | 2008-11-20 | 123511045 | 188d | 75d |  | PROCUREMENT<$50K 60 NO ESCALATION FY09 | 26,623.02 | CHUDAKOV | 1 | 1 | D | 07-027 | EUGENE C |  |  |  | 09-012 |  | 08-016 | EXP0809 |  |  |
| 123511050a |  | FY08 Exp Production of Drawings for Strong Back Supprt for Dipole Magnets. (TAG MAG) |  | 8d | 2008-09-19 | 2008-09-30 | 123511045 | 188d | 0d |  | VISTNG USERS [78.22 h] | 1,332.87 | CHUDAKOV | 1 | 1 | D | 07-027 | EUGENE C |  |  |  | 09-012 |  | 08-016 | EXP0809 |  |  |
| 123511050b |  | FY09 Exp Production of Drawings for Strong Back Supprt for Dipole Magnets. (TAG MAG) |  | 37d | 2008-10-01 | 2008-11-20 | 123511050a | 188d | 75d |  | VISTNG USERS [361.78 h] | 6,363.71 | CHUDAKOV | 1 | 1 | D | 07-027 | EUGENE C |  |  |  | 09-012 |  | 08-016 | EXP0809 |  |  |
| 123511055 |  | Re-Baseline Actuals Adjustment |  | 1d | 2013-08-30 | 2013-08-30 | 9-130M FS+227d | 20d |  |  | PROCUREMENT>$50K 69 NO ESCALATION | -111,185.11 | CHUDAKOV | 1 | 1 |  |  | EUGENE C |  |  |  |  |  |  |  | 13-014 | ADJ |

| ID | WBS | Activity | Type | Duration | Start | Finish | Predecessors | Total float | Free float | Constraint | Resources | Cost | Planned FinishUDF | RESP - Responsibility | STRT%COMP for CM EVM | FNSH%COMP for CM EVM | CR 07-014 | HALL D Related Milestones | CAM RESPONSIBLE | CR 09-012 | CR 07-027 | ACT BRIDGING FY SPLIT | EXPNS ACT BRIDGING FY SPLIT | Milestone Level | CR 13-014 | ReBaseline Actuals Adjustment |
| --- | --- | --- | --- | --- | --- | --- | --- | --- | --- | --- | --- | --- | --- | --- | --- | --- | --- | --- | --- | --- | --- | --- | --- | --- | --- | --- |
|  | 2 | **1.2.3.5.1.2 HODOSCOPE** |  |  | 2006-10-02 | 2009-03-19 |  |  |  |  |  |  |  |  |  |  |  |  |  |  |  |  |  |  |  |  |
| 123512005 |  | Develop design for the spectrometer hodoscope (HODO) |  | 80d | 2006-10-02 | 2007-02-01 | 9-070M | 113d | 0d |  | CONTRB UNIV LBR [504.4 h] |  | 2007-09-28 | CHUDAKOV | 1 | 1 | 07-014 | D | EUGENE C |  |  |  |  |  |  |  |
| 123512005A |  | Develop design for the spectrometer hodoscope (HODO) |  | 167d | 2007-02-02 | 2007-09-28 | 123512005 | 113d | 0d |  |  |  | 2007-09-28 | CHUDAKOV | 1 | 1 | 07-014 | D | EUGENE C | 09-012 |  |  |  |  |  |  |
| 123512010 |  | Dsgn Light Guides for Microscope (HODO) |  | 40d | 2007-10-01 | 2007-11-27 | 123512005A, 1155005A FS-60d | 113d | 0d |  | CONTRB UNIV LBR [320 h] |  |  | CHUDAKOV | 1 | 1 |  | D | EUGENE C |  | 07-027 |  |  |  |  |  |
| 123512015 |  | Dsgn Frame for Microscope (HODO) |  | 40d | 2007-11-28 | 2008-02-01 | 123512010 | 113d | 0d |  | CONTRB UNIV LBR [320 h] |  |  | CHUDAKOV | 1 | 1 |  | D | EUGENE C |  | 07-027 |  |  |  |  |  |
| 123512020 |  | Dsgn Frame for Fixed Array (HODO) |  | 40d | 2008-02-04 | 2008-03-31 | 123512015 | 113d | 0d |  | CONTRB UNIV LBR [320 h] |  |  | CHUDAKOV | 1 | 1 |  | D | EUGENE C |  | 07-027 |  |  |  |  |  |
| 123512025 |  | Dsgn Voltage Divider for Fixed Array PMT (HODO) |  | 40d | 2008-04-01 | 2008-05-27 | 123512020 | 113d | 0d |  | CONTRB UNIV LBR [320 h] |  |  | CHUDAKOV | 1 | 1 |  | D | EUGENE C |  | 07-027 |  |  |  |  |  |
| 123512030 |  | Dsgn Light Guides for Fixed Array (HODO) |  | 40d | 2008-05-28 | 2008-07-23 | 123512025 | 113d | 0d |  | CONTRB UNIV LBR [320 h] |  |  | CHUDAKOV | 1 | 1 |  | D | EUGENE C |  | 07-027 |  |  |  |  |  |
| 123512035 |  | Determine Assy Procedure for Fixed Array (HODO) |  | 40d | 2008-07-24 | 2008-09-18 | 123512030 | 113d | 0d |  | CONTRB UNIV LBR [320 h] |  |  | CHUDAKOV | 1 | 1 |  | D | EUGENE C |  | 07-027 |  |  |  |  |  |
| 123512040 |  | Dsgn Alignment for Microscope (HODO) |  | 40d | 2008-09-19 | 2008-11-13 | 123512035 | 113d | 0d |  | CONTRB UNIV LBR [280 h] |  |  | CHUDAKOV | 1 | 1 |  | D | EUGENE C |  | 07-027 | FY08-09 |  |  |  |  |
| 123512045 |  | Dsgn Cable Layout for Microscope (HODO) |  | 40d | 2008-11-14 | 2009-01-21 | 123512040 | 113d | 0d |  | CONTRB UNIV LBR [120 h] |  |  | CHUDAKOV | 1 | 1 |  | D | EUGENE C |  | 07-027 |  |  |  |  |  |
| 123512050 |  | Dsgn Cable Layout for Fixed Array (HODO) |  | 40d | 2009-01-22 | 2009-03-19 | 123512045 | 113d | 0d |  | CONTRB UNIV LBR [160 h] |  |  | CHUDAKOV | 1 | 1 |  | D | EUGENE C |  | 07-027 |  |  |  |  |  |
|  | 2 | **1.2.3.5.2 TARGET** |  |  |  |  |  |  |  |  |  |  |  |  |  |  |  |  |  |  |  |  |  |  |  |  |
|  | 3 | **1.2.3.5.3 BEAMLINE COMPONENTS** |  |  | 2006-10-02 | 2013-08-30 |  |  |  |  |  |  |  |  |  |  |  |  |  |  |  |  |  |  |  |  |
| 12353005 |  | Develop design for active collimator (BL COMPONENTS) |  | 79d | 2006-10-02 | 2007-02-01 | 9-070M | 93d | 1d |  | CONTRB UNIV LBR [116 h] |  | 2007-09-28 | CHUDAKOV | 1 | 1 | 07-014 | D | EUGENE C | 09-012 |  |  |  |  |  |  |
| 12353005A |  | Develop design for active collimator (BL COMPONENTS) |  | 268d | 2007-02-02 | 2008-03-04 | 12353005 | 92d | 0d | start on or after 2007-02-02 | PD UNIV STUDNT [320 h] | 3,041.82 | 2007-09-28 | CHUDAKOV | 1 | 1 | 07-014 | D | EUGENE C | 09-012 | 07-027 |  |  |  |  |  |
| 12353010 |  | Dsgn Active Collimator (BL Compnts) |  | 60d | 2007-09-04 | 2007-11-28 | 1155010A FS-60d, 12353005A FS-120d | 92d | 0d |  | CONTRB UNIV LBR [488 h] |  |  | CHUDAKOV | 1 | 1 |  | D | EUGENE C |  | 07-027 |  |  |  |  |  |
| 12353015 |  | Dsgn Photon Monitor (BL Compnts) |  | 60d | 2007-11-29 | 2008-03-04 | 12353010 | 92d | 0d |  | PD UNIV STUDNT [312 h] | 2,935.92 |  | CHUDAKOV | 1 | 1 |  | D | EUGENE C |  | 07-027 |  |  |  |  |  |
| 12353020 |  | Dsgn Feedback Mechanism (BL Compnts) |  | 110d | 2008-03-05 | 2008-08-07 | 12353015 | 92d | 0d |  | SCIENTIST [880 h] | 54,797.6 |  | CHUDAKOV | 1 | 1 |  | D | EUGENE C |  | 07-027 |  |  |  |  |  |
| 12353025 |  | FY08 Exp Dsgn Display of Beam Position (BL Compnts) |  | 97d | 2008-05-14 | 2008-09-30 | 12353020 FS-60d | 92d | 0d |  | SCIENTIST [776 h] | 48,321.52 |  | CHUDAKOV | 1 | 1 |  | D | EUGENE C |  | 07-027 | FY08-09 | EXP0809 |  |  |  |
| 12353025a |  | FY09 Exp Dsgn Display of Beam Position (BL Compnts) |  | 13d | 2008-10-01 | 2008-10-17 | 12353025 | 92d | 0d |  | SCIENTIST [104 h] | 6,683.04 |  | CHUDAKOV | 1 | 1 |  | D | EUGENE C |  | 07-027 | FY08-09 | EXP0809 |  |  |  |
| 12353030 |  | Dsgn BL Configuration (BL Compnts) |  | 60d | 2008-10-20 | 2009-01-22 | 12353025a | 92d | 0d |  | SCIENTIST [440 h] | 28,274.4 |  | CHUDAKOV | 1 | 1 |  | D | EUGENE C |  | 07-027 |  |  |  |  |  |
| 12353035 |  | Integrate Goniometer into BL (BL Compnts) |  | 60d | 2009-01-23 | 2009-04-17 | 1155020, 12353030, 1155025 | 92d | 0d |  | SCIENTIST [440 h] | 28,274.4 |  | CHUDAKOV | 1 | 1 |  | D | EUGENE C |  | 07-027 |  |  |  |  |  |
| 12353040 |  | Final Dsgn & Safty Assessmnt of Beam Line Compnts |  | 10d | 2009-04-20 | 2009-05-01 | 12353035 | 92d | 0d |  |  |  |  | CHUDAKOV | 1 | 1 |  | D | EUGENE C |  | 07-027 |  |  |  |  |  |
| 12353045M |  | Beam Line Components Dsgn Rquirmnts Finalized | milestone | 0d | 2009-05-20 | 2009-05-20 | 12353040 FS+13d | 92d | 0d |  |  |  |  | CHUDAKOV | 1 | 1 |  | D | EUGENE C |  | 07-027 |  |  | 6 |  |  |
| 12353050 |  | Re-Baseline Actuals Adjustment |  | 1d | 2013-08-30 | 2013-08-30 | 9-130M FS+227d | 20d |  |  | PROCUREMENT>$50K 69 NO ESCALATION | -4,368.15 |  | CHUDAKOV | 1 | 1 |  |  | EUGENE C |  |  |  |  |  | 13-014 | ADJ |

| ID | WBS | Activity | Type | Duration | Start | Finish | Predecessors | Total float | Free float | Resources | Cost | RESP - Responsibility | STRT%COMP for CM EVM | FNSH%COMP for CM EVM | Milestone Level | HALL D Related Milestones | CR 07-027 | CAM RESPONSIBLE | ACT BRIDGING FY SPLIT | CR 13-014 | ReBaseline Actuals Adjustment | Planned FinishUDF | CR 09-012 |
| --- | --- | --- | --- | --- | --- | --- | --- | --- | --- | --- | --- | --- | --- | --- | --- | --- | --- | --- | --- | --- | --- | --- | --- |
|  | 6 | **1.2.3.6 INFRASTRUCTURE** |  |  | 2008-10-01 | 2013-08-30 |  |  |  |  |  |  |  |  |  |  |  |  |  |  |  |  |  |
|  | 1 | **1.2.3.6.1 ASSEMBLY** |  |  | 2008-10-01 | 2013-08-30 |  |  |  |  |  |  |  |  |  |  |  |  |  |  |  |  |  |
| 12361000M |  | Starting Milestone for FY09 (Assy) | milestone | 0d | 2008-10-01 | 2008-10-01 | 9-090M | 58d | 0d |  |  | CHUDAKOV | 1 | 1 | 6 | D | 07-027 | EUGENE C |  |  |  |  |  |
| 12361005 |  | Develop Alignment of DCs (Assy)+ |  | 90d | 2008-10-01 | 2009-02-17 | 12361000M | 158d |  | MECH TECH [440 h] | 17,798 | CHUDAKOV | 1 | 1 |  | D | 07-027 | EUGENE C |  |  |  |  |  |
| 12361010 |  | Develop Installtn of Bcal (Assy)+ |  | 90d | 2009-03-04 | 2009-07-09 | 12361000M FS+100d | 58d |  | MECH TECH [440 h] | 17,798 | CHUDAKOV | 1 | 1 |  | D | 07-027 | EUGENE C | FY08-09 |  |  |  |  |
| 12361015 |  | Re-Baseline Actuals Adjustment |  | 1d | 2013-08-30 | 2013-08-30 | 9-130M FS+227d | 20d |  | PROCUREMENT>$50K 69 NO ESCALATION | -1,986.49 | CHUDAKOV | 1 | 1 |  |  |  | EUGENE C |  | 13-014 | ADJ |  |  |
|  | 2 | **1.2.3.6.2 INSTALLATION** |  |  |  |  |  |  |  |  |  |  |  |  |  |  |  |  |  |  |  |  |  |
|  | 3 | **1.2.3.6.3 CRYOGENICS** |  |  |  |  |  |  |  |  |  |  |  |  |  |  |  |  |  |  |  |  |  |
|  | 4 | **1.2.4 CONVENTIONAL FACILITIES** |  |  | 2006-10-02 | 2013-08-30 |  |  |  |  |  |  |  |  |  |  |  |  |  |  |  |  |  |
|  | 1 | **1.2.4.1 ACCELERATOR** |  |  | 2006-10-02 | 2013-08-30 |  |  |  |  |  |  |  |  |  |  |  |  |  |  |  |  |  |
| 1241000M |  | Begin Design N&S Access Building Additions | milestone | 0d | 2006-10-02 | 2006-10-02 | 9-070M | 140d | 0d |  |  | WHITLATCH C | 1 | 1 | 6 |  |  | REBECCA Y |  |  |  | 2006-10-02 |  |
| 1241005 |  | Develop N&S Addition Preliminary Design (ACCEL) |  | 30d | 2006-10-02 | 2006-11-10 | 1241000M | 140d | 0d | PLANT ENG [40 h] | 2,501.6 | WHITLATCH C | 1 | 1 |  |  |  | REBECCA Y |  |  |  | 2006-11-10 |  |
| 1241010 |  | Conduct N&S Addition Prelim Design & Safety Review |  | 20d | 2006-11-13 | 2006-12-12 | 1241005 | 140d | 0d | PLANT ENG [80 h] | 5,003.2 | WHITLATCH C | 1 | 1 |  |  |  | REBECCA Y |  |  |  | 2006-12-12 |  |
| 1241080M |  | Begin Design Beam Switch Yard Addition (ACCEL) | milestone | 0d | 2006-11-13 | 2006-11-13 | 1241005 | 155d | 0d |  |  | WHITLATCH C | 1 | 1 | 6 |  |  | REBECCA Y |  |  |  | 2006-11-13 |  |
| 1241085 |  | Develop BSY Addition 35% Design (ACCEL) |  | 80d | 2006-11-13 | 2007-03-16 | 1241080M | 155d | 0d | MECH DES [40 h]; PLANT ENG [360 h] | 24,287.6 | WHITLATCH C | 1 | 1 |  |  |  | REBECCA Y |  |  |  | 2007-03-16 | 09-012 |
| 1241015 |  | Conduct N&S Addition Cost Validation (ACCEL) |  | 10d | 2006-12-13 | 2007-01-03 | 1241010 | 245d | 0d |  |  | WHITLATCH C | 1 | 1 |  |  |  | REBECCA Y |  |  |  | 2007-01-03 | 09-012 |
| 1241040M |  | Begin Design N&S Access Building Utilities (ACCEL) | milestone | 0d | 2006-12-13 | 2006-12-13 | 1241010, 1241000M | 140d | 0d |  |  | WHITLATCH C | 1 | 1 | 6 |  |  | REBECCA Y |  |  |  | 2006-12-13 |  |
| 1241045 |  | Develop N&S Utilities 35% Design (ACCEL) |  | 40d | 2006-12-13 | 2007-02-15 | 1241040M | 140d | 0d | OFFICE [120 h]; MECH DES [40 h]; PLANT ENG [240 h] | 19,876.4 | WHITLATCH C | 1 | 1 |  |  |  | REBECCA Y |  |  |  | 2007-02-15 | 09-012 |
| 1241016M |  | N&S Access Building Preliminary Design Complete | milestone | 0d | 2007-01-03 | 2007-01-03 | 1241015 | 245d |  |  |  | WHITLATCH C | 1 | 1 | 5 |  |  | REBECCA Y |  |  |  | 2007-01-03 |  |
| 1241050 |  | Conduct N&S Utilities 35% Design & Safety Review |  | 40d | 2007-02-16 | 2007-04-13 | 1241045 | 155d | 0d | PLANT ENG [80 h] | 4,984 | WHITLATCH C | 1 | 1 |  |  |  | REBECCA Y |  |  |  | 2007-04-13 |  |
| 1241120M |  | Begin Design Tunnel A/C (ACCEL) | milestone | 0d | 2007-02-16 | 2007-02-16 | 1241045 | 140d | 0d |  |  | WHITLATCH C | 1 | 1 | 6 |  |  | REBECCA Y |  |  |  | 2007-02-16 |  |
| 1241125 |  | Develop Tunnel A/C 35% Design (ACCEL) |  | 45d | 2007-02-16 | 2007-04-20 | 1241120M | 140d | 0d | PLANT ENG [160 h]; MECH DES [40 h] | 11,720.4 | WHITLATCH C | 1 | 1 |  |  |  | REBECCA Y |  |  |  | 2007-04-20 | 09-012 |
| 1241160M |  | Begin Design N&S Linac Power (ACCEL) | milestone | 0d | 2007-02-16 | 2007-02-16 | 1241045 | 165d | 0d |  |  | WHITLATCH C | 1 | 1 | 6 |  |  | REBECCA Y |  |  |  | 2007-02-16 |  |
| 1241165 |  | Develop N&S Linac 35% Design (ACCEL) |  | 30d | 2007-02-16 | 2007-03-30 | 1241160M | 165d | 0d | PLANT ENG [120 h] | 7,504.8 | WHITLATCH C | 1 | 1 |  |  |  | REBECCA Y |  |  |  | 2007-03-30 |  |
| 1241090 |  | Conduct BSY Addition 35% Design & Safety Review |  | 20d | 2007-03-19 | 2007-04-13 | 1241085 | 155d | 0d | PLANT ENG [80 h] | 4,964.8 | WHITLATCH C | 1 | 1 |  |  |  | REBECCA Y |  |  |  | 2007-04-13 |  |
| 1241170 |  | Conduct N&S Linac 35% Design & Safety Review |  | 10d | 2007-04-02 | 2007-04-13 | 1241165 | 165d | 0d | PLANT ENG [40 h] | 2,463.2 | WHITLATCH C | 1 | 1 |  |  |  | REBECCA Y |  |  |  | 2007-04-13 |  |
| 1241055 |  | Conduct N&S Utilities Cost Validation (ACCEL) |  | 20d | 2007-04-16 | 2007-05-11 | 1241050 | 155d | 0d | PLABOR | 3,095 | WHITLATCH C | 1 | 1 |  |  |  | REBECCA Y |  |  |  | 2007-05-11 |  |
| 1241095 |  | Conduct BSY Addition Cost Validation (ACCEL) |  | 20d | 2007-04-16 | 2007-05-11 | 1241090 | 155d | 0d | PLABOR | 3,095 | WHITLATCH C | 1 | 1 |  |  |  | REBECCA Y |  |  |  | 2007-05-11 |  |
| 1241175 |  | Conduct N&S Linac Cost Validation (ACCEL) |  | 10d | 2007-04-16 | 2007-04-27 | 1241170 | 165d | 0d | PLABOR | 3,095 | WHITLATCH C | 1 | 1 |  |  |  | REBECCA Y |  |  |  | 2007-04-27 |  |
| 1241130 |  | Conduct Tunnel A/C 35% Design & Safety Review |  | 20d | 2007-04-23 | 2007-05-18 | 1241125 | 140d | 0d | PLANT ENG [40 h] | 2,463.2 | WHITLATCH C | 1 | 1 |  |  |  | REBECCA Y |  |  |  | 2007-05-18 |  |
| 1241176M |  | N&S Linac Preliminary Design Complete | milestone | 0d | 2007-04-27 | 2007-04-27 | 1241175 | 165d |  |  |  | WHITLATCH C | 1 | 1 | 5 |  |  | REBECCA Y |  |  |  | 2007-04-27 |  |
| 1241056M |  | N&S Utilities Building Preliminary Design Complete | milestone | 0d | 2007-05-11 | 2007-05-11 | 1241055 | 155d |  |  |  | WHITLATCH C | 1 | 1 | 5 |  |  | REBECCA Y |  |  |  | 2007-05-11 |  |
| 1241096M |  | BSY Addition Preliminary Design Complete (ACCEL) | milestone | 0d | 2007-05-11 | 2007-05-11 | 1241095 | 155d |  |  |  | WHITLATCH C | 1 | 1 | 5 |  |  | REBECCA Y |  |  |  | 2007-05-11 |  |
| 1241135 |  | Conduct Tunnel A/C Cost Validation (ACCEL) |  | 10d | 2007-05-21 | 2007-06-04 | 1241130 | 140d | 0d | PLABOR | 3,095 | WHITLATCH C | 1 | 1 |  |  |  | REBECCA Y |  |  |  | 2007-06-04 |  |
| 1241136M |  | Tunnel A/C Preliminary Design Complete (ACCEL) | milestone | 0d | 2007-06-04 | 2007-06-04 | 1241135 | 140d |  |  |  | WHITLATCH C | 1 | 1 | 5 |  |  | REBECCA Y |  |  |  | 2007-06-04 |  |
| 1241020 |  | Develop N&S ADDITION 100% Dsgn (ACCEL) |  | 60d | 2007-10-01 | 2008-01-03 | 9-080M | 26d | 0d | MECH ENG [80 h]; MECH DES [40 h]; OFFICE [120 h]; PLABOR; PLANT ENG [280 h]; ELEC ENG [80 h] | 33,056.06 | WHITLATCH C | 1 | 1 |  |  | 07-027 | REBECCA Y |  |  |  |  |  |
| 1241060 |  | Develop N&S UTILITIES 100% Dsgn (ACCEL) |  | 60d | 2007-10-01 | 2008-01-03 | 9-080M | 16d | 0d | MECH DES [40 h]; PLABOR; ELEC ENG [80 h]; MECH ENG [360 h]; OFFICE [80 h] | 34,154.09 | WHITLATCH C | 1 | 1 |  |  | 07-027 | REBECCA Y |  |  |  |  |  |
| 1241180 |  | Develop N&S LINAC 100% Dsgn (ACCEL) |  | 60d | 2007-11-28 | 2008-03-03 | 9-080M FS+40d | 26d | 0d | ELEC ENG [240 h]; MECH DES [40 h]; OFFICE [40 h]; PLABOR | 18,717.18 | WHITLATCH C | 1 | 1 |  |  | 07-027 | REBECCA Y |  |  |  |  |  |
| 1241025 |  | Conduct N&S ADDITION 100% Dsgn & Safty Review |  | 20d | 2008-01-04 | 2008-02-01 | 1241020 | 26d | 0d | PLANT ENG [80 h] | 4,956 | WHITLATCH C | 1 | 1 |  |  | 07-027 | REBECCA Y |  |  |  |  |  |
| 1241065 |  | Conduct N&S UTILITIES100% Dsgn & Safty Review |  | 20d | 2008-01-04 | 2008-02-01 | 1241060 | 116d | 0d | MECH ENG [40 h] | 2,473.6 | WHITLATCH C | 1 | 1 |  |  | 07-027 | REBECCA Y |  |  |  |  |  |
| 1241140 |  | Develop TUNNEL A/C 100% Dsgn (ACCEL) |  | 60d | 2008-01-04 | 2008-03-31 | 9-080M, 1241060 | 16d | 0d | OFFICE [40 h]; ELEC ENG [80 h]; MECH ENG [200 h]; PLABOR | 20,480.11 | WHITLATCH C | 1 | 1 |  |  | 07-027 | REBECCA Y |  |  |  |  |  |
| 1241030 |  | Develop N&S ADDITION Final Dsgn (ACCEL) |  | 20d | 2008-02-04 | 2008-03-03 | 1241025 | 106d | 0d | PLANT ENG [80 h] | 4,956 | WHITLATCH C | 1 | 1 |  |  | 07-027 | REBECCA Y |  |  |  |  |  |
| 1241070 |  | Develop N&S UTILITIES Final Dsgn (ACCEL) |  | 10d | 2008-02-04 | 2008-02-15 | 1241065 | 116d | 0d | MECH ENG [40 h] | 2,473.6 | WHITLATCH C | 1 | 1 |  |  | 07-027 | REBECCA Y |  |  |  |  |  |
| 1241100 |  | Develop BSY ADDITION 100% Dsgn (ACCEL) |  | 60d | 2008-02-04 | 2008-04-28 | 1241025, 9-080M | 26d | 0d | PLANT ENG [280 h]; PLABOR; ELEC ENG [80 h]; OFFICE [120 h]; MECH ENG [40 h]; MECH DES [40 h] | 31,645.31 | WHITLATCH C | 1 | 1 |  |  | 07-027 | REBECCA Y |  |  |  |  |  |
| 1241075M |  | Comp Dsgn N&S UTILITIES (ACCEL)+ | milestone | 0d | 2008-02-15 | 2008-02-15 | 1241070 | 158d | 140d |  |  | WHITLATCH C | 1 | 1 | 6 |  | 07-027 | REBECCA Y |  |  |  |  |  |
| 1241035M |  | Comp Dsgn N&S Access Bldng ADDITION+ | milestone | 0d | 2008-03-03 | 2008-03-03 | 1241030 | 396d |  |  |  | WHITLATCH C | 1 | 1 | 6 |  | 07-027 | REBECCA Y |  |  |  |  |  |
| 1241185 |  | Conduct N&S LINAC 100% Dsgn & Safty Review |  | 40d | 2008-03-04 | 2008-04-28 | 1241180 | 26d | 0d | ELEC ENG [40 h] | 2,489.6 | WHITLATCH C | 1 | 1 |  |  | 07-027 | REBECCA Y |  |  |  |  |  |
| 1241145 |  | Conduct TUNNEL A/C 100% Dsgn & Safty Review |  | 40d | 2008-04-01 | 2008-05-27 | 1241140 | 16d | 0d | MECH ENG [40 h] | 2,473.6 | WHITLATCH C | 1 | 1 |  |  | 07-027 | REBECCA Y |  |  |  |  |  |
| 1241105 |  | Conduct BSY ADDITION 100% Dsgn & Safty Review |  | 20d | 2008-04-29 | 2008-05-27 | 1241100 | 26d | 0d | PLANT ENG [40 h] | 2,478 | WHITLATCH C | 1 | 1 |  |  | 07-027 | REBECCA Y |  |  |  |  |  |
| 1241190 |  | Develop N&S LINAC Final Dsgn (ACCEL) |  | 40d | 2008-04-29 | 2008-06-24 | 1241185 | 26d | 0d | ELEC ENG [40 h] | 2,489.6 | WHITLATCH C | 1 | 1 |  |  | 07-027 | REBECCA Y |  |  |  |  |  |
| 1241110 |  | Develop BSY ADDITION Final Dsgn (ACCEL) |  | 20d | 2008-05-28 | 2008-06-24 | 1241105 | 26d | 0d | PLANT ENG [40 h] | 2,478 | WHITLATCH C | 1 | 1 |  |  | 07-027 | REBECCA Y |  |  |  |  |  |
| 1241150 |  | Develop TUNNEL A/C Final Dsgn (ACCEL) |  | 30d | 2008-05-28 | 2008-07-09 | 1241145 | 16d | 0d | MECH ENG [40 h] | 2,473.6 | WHITLATCH C | 1 | 1 |  |  | 07-027 | REBECCA Y |  |  |  |  |  |
| 1241115M |  | Comp Dsgn Beam Switch Yard (BSY) ADDITION | milestone | 0d | 2008-06-24 | 2008-06-24 | 1241110 | 68d | 50d |  |  | WHITLATCH C | 1 | 1 | 6 |  | 07-027 | REBECCA Y |  |  |  |  |  |
| 1241195M |  | Comp Dsgn N&S LINAC Pwr (ACCEL)++ | milestone | 0d | 2008-06-24 | 2008-06-24 | 1241190 | 68d | 50d |  |  | WHITLATCH C | 1 | 1 | 6 |  | 07-027 | REBECCA Y |  |  |  |  |  |
| 1241155M |  | Comp Dsgn TUNNEL A/C (ACCEL)+ | milestone | 0d | 2008-07-09 | 2008-07-09 | 1241150 | 58d | 40d |  |  | WHITLATCH C | 1 | 1 | 6 |  | 07-027 | REBECCA Y |  |  |  |  |  |
| 1241200 |  | Re-Baseline Actuals Adjustment |  | 1d | 2013-08-30 | 2013-08-30 | 9-130M FS+227d | 20d |  | PROCUREMENT>$50K 69 NO ESCALATION | 119,529.34 | WHITLATCH C | 1 | 1 |  |  |  | REBECCA Y |  | 13-014 | ADJ |  |  |

| ID | WBS | Activity | Type | Duration | Start | Finish | Predecessors | Total float | Free float | Resources | Cost | Planned FinishUDF | RESP - Responsibility | STRT%COMP for CM EVM | FNSH%COMP for CM EVM | Milestone Level | CAM RESPONSIBLE | CR 08-058 | CR 13-014 | ReBaseline Actuals Adjustment | CR 07-018 | CR 07-021 | CR 09-012 | CR 07-027 | CR 08-016 | CR 08-017 | CR 10-042 | CR 10-061 | EXPNS ACT BRIDGING FY SPLIT | CR 08-026 |
| --- | --- | --- | --- | --- | --- | --- | --- | --- | --- | --- | --- | --- | --- | --- | --- | --- | --- | --- | --- | --- | --- | --- | --- | --- | --- | --- | --- | --- | --- | --- |
|  | 2 | **1.2.4.2 CHL** |  |  | 2006-10-02 | 2013-08-30 |  |  |  |  |  |  |  |  |  |  |  |  |  |  |  |  |  |  |  |  |  |  |  |  |
| 1242005M |  | Begin Design CHL Addition (CHL) | milestone | 0d | 2006-10-02 | 2006-10-02 | 9-070M | 313d | 0d |  |  | 2006-10-02 | YASKY R | 1 | 1 | 6 | REBECCA Y |  |  |  |  |  |  |  |  |  |  |  |  |  |
| 1242010 |  | Develop CHL 60% Design (CHL) |  | 40d | 2006-10-02 | 2006-11-28 | 1242005M | 313d | 0d |  |  | 2006-11-28 | YASKY R | 1 | 1 |  | REBECCA Y |  |  |  |  |  |  |  |  |  |  |  |  |  |
| 1242015 |  | Conduct CHL 60% Design & Safety Review |  | 15d | 2006-11-29 | 2006-12-19 | 1242010 | 313d | 0d | PLANT ENG [240 h] | 15,009.6 | 2006-12-19 | YASKY R | 1 | 1 |  | REBECCA Y |  |  |  |  |  |  |  |  |  |  |  |  |  |
| 1242015M |  | 60% Design CHL Complete | milestone | 0d | 2006-12-19 | 2006-12-19 | 1242015 | 313d | 0d |  |  | 2006-12-19 | YASKY R | 1 | 1 | 5 | REBECCA Y |  |  |  |  |  |  |  |  |  |  |  |  |  |
| 1242020 |  | Develop CHL 100% Design (CHL) |  | 45d | 2006-12-20 | 2007-03-02 | 1242015M | 313d | 0d | PROCUREMENT>$50K 69; PROCUREMENT<$50K 60 | 61,920 | 2007-03-02 | YASKY R | 1 | 1 |  | REBECCA Y |  |  |  |  |  |  |  |  |  |  |  |  |  |
| 1242025 |  | Conduct CHL 100% Design & Safety Review |  | 20d | 2007-03-05 | 2007-03-30 | 1242020 | 313d | 0d | PLANT ENG [480 h] | 30,019.2 | 2007-03-30 | YASKY R | 1 | 1 |  | REBECCA Y |  |  |  |  |  |  |  |  |  |  |  |  |  |
| 1242025M |  | 100% Design CHL Complete | milestone | 0d | 2007-03-30 | 2007-03-30 | 1242025 | 313d | 0d |  |  | 2007-03-30 | YASKY R | 1 | 1 | 5 | REBECCA Y |  |  |  |  |  |  |  |  |  |  |  |  |  |
| 1242030 |  | Develop CHL Final Design (CHL) |  | 10d | 2007-04-02 | 2007-04-13 | 1242025M | 313d | 0d | PROCUREMENT>$50K 69 | 20,640 | 2007-04-13 | YASKY R | 1 | 1 |  | REBECCA Y |  |  |  |  |  |  |  |  |  |  |  |  |  |
| 1242035 |  | Conduct CHL Final Design & Safety Review |  | 10d | 2007-04-16 | 2007-04-27 | 1242030 | 313d | 0d | OFFICE [40 h]; PLANT ENG [80 h] | 5,956 | 2007-04-27 | YASKY R | 1 | 1 |  | REBECCA Y |  |  |  |  |  |  |  |  |  |  |  |  |  |
| 1242040M |  | Complete Design CHL Addition (CHL) | milestone | 0d | 2007-04-27 | 2007-04-27 | 1242035 | 313d |  |  |  | 2007-04-27 | YASKY R | 1 | 1 | 5 | REBECCA Y |  |  |  |  |  |  |  |  |  |  |  |  |  |
| 1621000MX |  | CHL Addition Begin Proc Prep | milestone | 0d | 2008-10-01 | 2008-10-01 | 9-090M | 72d | 0d |  |  |  | YASKY R | 1 | 1 | 6 | REBECCA Y | 08-058 |  |  |  |  |  |  |  |  |  |  |  |  |
| 1621005X |  | Prcrmnt Prep for CHL Addition to Award Contract |  | 59d | 2008-10-01 | 2008-12-24 | 1621000MX | 72d | 0d | PLANT ENG [67.43 h] | 4,310.8 |  | YASKY R | 1 | 1 |  | REBECCA Y | 08-058 |  |  |  |  |  |  |  |  |  |  |  |  |
| 1242045 |  | Re-Baseline Actuals Adjustment |  | 1d | 2013-08-30 | 2013-08-30 | 9-130M FS+227d | 20d |  | PROCUREMENT>$50K 69 NO ESCALATION | -28,129.35 |  | YASKY R | 1 | 1 |  | REBECCA Y |  | 13-014 | ADJ |  |  |  |  |  |  |  |  |  |  |
|  | 3 | **1.2.4.3 HALL D** |  |  | 2006-10-02 | 2013-08-30 |  |  |  |  |  |  |  |  |  |  |  |  |  |  |  |  |  |  |  |  |  |  |  |  |
| 1243005M |  | Begin Definitive Design Hall D Complex | milestone | 0d | 2006-10-02 | 2006-10-02 | 9-070M | 15d | 0d |  |  | 2006-10-02 | YASKY R | 1 | 1 | 6 | REBECCA Y |  |  |  |  |  |  |  |  |  |  |  |  |  |
| 1243010 |  | Develop Hall D 60% Design (HALL D) |  | 45d | 2006-10-02 | 2006-12-05 | 1243005M | 15d | 0d | PROCUREMENT<$50K 60; PROCUREMENT>$50K 69 | 69,712 | 2006-12-05 | YASKY R | 1 | 1 |  | REBECCA Y |  |  |  |  |  |  |  |  |  |  |  |  |  |
| 1243015 |  | Conduct Hall D 60% Design & Safety Review |  | 25d | 2006-12-06 | 2007-01-18 | 1243010 | 15d | 0d | OFFICE [120 h]; PLANT ENG [1000 h] | 65,633.6 | 2007-01-18 | YASKY R | 1 | 1 |  | REBECCA Y |  |  |  |  |  |  |  |  |  |  |  |  |  |
| 1243015M |  | 60% Design Hall D Complete | milestone | 0d | 2007-01-18 | 2007-01-18 | 1243015 | 15d | 0d |  |  | 2007-01-18 | YASKY R | 1 | 1 | 5 | REBECCA Y |  |  |  |  |  |  |  |  |  |  |  |  |  |
| 1243018 |  | Independent Cost Validation |  | 42d | 2007-04-23 | 2007-06-20 | 1243015M FS+65d | 93d | 78d | PROCUREMENT<$50K 60 | 37,000 | 2007-01-18 | YASKY R | 1 | 1 |  | REBECCA Y |  |  |  | 07-018 |  |  |  |  |  |  |  |  |  |
| 1243020 |  | Develop Hall D 100% Design (HALL D) |  | 60d | 2007-05-21 | 2007-08-14 | 1243015M FS+85d | 15d | 0d | PROCUREMENT<$50K 60 | 80,000 | 2007-04-13 | YASKY R | 1 | 1 |  | REBECCA Y |  |  |  | 07-018 | 07-021 | 09-012 |  |  |  |  |  |  |  |
| 1243021 |  | Develop Hall D Civil Commissioning Plan |  | 60d | 2007-05-21 | 2007-08-14 | 1243015M FS+85d | 15d | 0d | PROCUREMENT<$50K 60 | 20,000 | 2007-01-18 | YASKY R | 1 | 1 |  | REBECCA Y |  |  |  | 07-018 |  |  |  |  |  |  |  |  |  |
| 1243025 |  | Conduct Hall D 100% Design & Safety Review |  | 40d | 2007-08-15 | 2007-10-10 | 1243021, 1243020 | 15d | 0d | PROCUREMENT<$50K 60 NO ESCALATION FY08; PLANT ENG [680 h] | 77,084.51 | 2007-05-25 | YASKY R | 1 | 1 |  | REBECCA Y |  |  |  | 07-018 |  | 09-012 | 07-027 | 08-016 | 08-017 |  |  |  |  |
| 1243025M |  | 100% Design Hall D Complete | milestone | 0d | 2007-10-10 | 2007-10-10 | 1243018, 1243025 | 15d | 0d |  |  | 2007-05-25 | YASKY R | 1 | 1 | 5 | REBECCA Y |  |  |  | 07-018 |  |  | 07-027 |  |  |  |  |  |  |
| 1243030 |  | Develop Hall D Final Design (HALL D) |  | 20d | 2007-10-11 | 2007-11-07 | 1243025M | 15d | 0d | PROCUREMENT>$50K 69 | 68,154.93 | 2007-06-18 | YASKY R | 1 | 1 |  | REBECCA Y |  |  |  | 07-018 |  |  | 07-027 |  |  |  |  |  |  |
| 1243035 |  | Conduct Hall D Final Design & Safety Review |  | 15d | 2007-11-08 | 2007-11-30 | 1243030 | 15d | 0d | PLANT ENG [240 h] | 14,868 | 2007-07-02 | YASKY R | 1 | 1 |  | REBECCA Y |  |  |  | 07-018 |  | 09-012 | 07-027 |  |  |  |  |  |  |
| 1243040M |  | Complete Design Hall D Complete (HALL D) | milestone | 0d | 2007-11-30 | 2007-11-30 | 1243035 | 15d | 0d |  |  | 2007-07-02 | YASKY R | 1 | 1 | 5 | REBECCA Y |  |  |  | 07-018 |  |  | 07-027 |  | 08-017 |  |  |  |  |
| 1243045 |  | Obtain Permit to Dispose of Dewater Effleuent (HALL D)+ |  | 90d | 2007-12-03 | 2008-04-17 | 1243035 | 256d | 194d | PROCUREMENT<$50K 60; PLANT ENG [160 h] | 40,869 | 2007-07-02 | YASKY R | 1 | 1 |  | REBECCA Y |  |  |  |  |  |  | 07-027 |  |  | 10-042 | 10-061 |  |  |
| 1243050 |  | PROC Procurement Prep to Award Hall D Contract |  | 195d | 2008-01-02 | 2008-10-07 | 1243040M FS+15d | 136d | 74d | PROCUREMENT<$50K 60 NO ESCALATION FY09 | 25,797.5 | 2007-07-02 | YASKY R | 1 | 1 |  | REBECCA Y |  |  |  |  |  | 09-012 | 07-027 |  | 08-017 | 10-042 | 10-061 | EXP0809 |  |
| 1243050a |  | FY08 Exp Procurement Prep to Award Hall D Contract |  | 190d | 2008-01-02 | 2008-09-30 | 1243040M FS+15d | 136d | 0d | ELEC ENG [233.85 h]; MECH ENG [272.82 h]; PLANT ENG [38.97 h] | 33,840.2 | 2007-07-02 | YASKY R | 1 | 1 |  | REBECCA Y |  |  |  |  |  | 09-012 | 07-027 |  | 08-017 | 10-042 | 10-061 | EXP0809 |  |
| 1243055 |  | Hall D Survey Network |  | 20d | 2008-08-04 | 2008-08-29 | 1243040M FS+164d | 162d | 100d | MECH TECH [200 h]; MECH ENG [80 h]; PROCUREMENT<$50K 60 | 18,787.2 | 2007-07-02 | YASKY R | 1 | 1 |  | REBECCA Y |  |  |  |  |  |  |  |  |  | 10-042 | 10-061 |  | 08-026 |
| 1243050b |  | FY09 Exp Procurement Prep to Award Hall D Contract |  | 5d | 2008-10-01 | 2008-10-07 | 1243050a | 136d | 74d | MECH ENG [7.18 h]; PLANT ENG [1.03 h]; ELEC ENG [6.15 h] | 919.02 | 2007-07-02 | YASKY R | 1 | 1 |  | REBECCA Y |  |  |  |  |  | 09-012 | 07-027 |  | 08-017 | 10-042 | 10-061 | EXP0809 |  |
| 1243060 |  | Re-Baseline Actuals Adjustment |  | 1d | 2013-08-30 | 2013-08-30 | 9-130M FS+227d | 20d |  | PROCUREMENT>$50K 69 NO ESCALATION | 60,649.89 |  | YASKY R | 1 | 1 |  | REBECCA Y |  | 13-014 | ADJ |  |  |  |  |  |  |  |  |  |  |

Notes:
- 1621000MX: Entry Criteria: Predecessor 1242040M (CHL Design / Completed)

| ID | WBS | Activity | Type | Duration | Start | Finish | Predecessors | Total float | Free float | Resources | Cost | Planned FinishUDF | RESP - Responsibility | Special | STRT%COMP for CM EVM | FNSH%COMP for CM EVM | CAM RESPONSIBLE | CR 09-012 | CR 08-032 | CR 08-058 | CR 13-014 | ReBaseline Actuals Adjustment | Milestone Level | CR 07-027 | ACT BRIDGING FY SPLIT |
| --- | --- | --- | --- | --- | --- | --- | --- | --- | --- | --- | --- | --- | --- | --- | --- | --- | --- | --- | --- | --- | --- | --- | --- | --- | --- |
|  | 5 | **1.2.5 PROJECT MANAGEMENT** |  |  | 2006-10-02 | 2013-08-30 |  |  |  |  |  |  |  |  |  |  |  |  |  |  |  |  |  |  |  |
|  | 1 | **1.2.5.1 PED PROJECT MANAGEMENT PROJECT OFFICE (DIR, PM, APM'S)** |  |  | 2006-10-02 | 2013-08-30 |  |  |  |  |  |  |  |  |  |  |  |  |  |  |  |  |  |  |  |
| 1251006RKC |  | FY06 Obligations RKC |  | 120d | 2006-10-02 | 2007-03-30 | 9-070M | 333d |  | PLABOR | 6,143.5 | 2007-03-30 | PARKINSON J | LR | 1 | 1 | CLAUS R |  |  |  |  |  |  |  |  |
| 1251007LOE |  | FY07 Project Management Project Office |  | 247d | 2006-10-02 | 2007-09-28 | 9-070M | 1d | 0d | DIRECTORATE [720 h]; SCIENTIST [880 h]; ELEC ENG [2640 h]; SR STAFF [4400 h]; ADMIN [880 h]; SUPPLIES & MATERIALS | 914,700.08 | 2007-09-28 | PARKINSON J |  | 1 | 1 | CLAUS R | 09-012 |  |  |  |  |  |  |  |
| 1251908LOE |  | FY08 PED Proj Office Proj Mngmnt P-1 |  | 142d | 2007-10-01 | 2008-04-30 | 1251007LOE | 1d | 0d | DIRECTORATE [412.26 h]; SCIENTIST [366.45 h]; ADMIN [503.87 h]; SR STAFF [3728.65 h]; OFFICE [503.87 h]; ELEC ENG [664.19 h]; SUPPLIES & MATERIALS; MECH ENG [297.74 h] | 629,473.48 |  | PARKINSON J |  | 1 | 1 | CLAUS R |  | 08-032 |  |  |  |  |  |  |
| 1251908LOEB |  | FY08 PED Proj Office Proj Mngmnt P-2 |  | 106d | 2008-05-01 | 2008-09-30 | 1251908LOE | 1d | 0d | ELEC ENG [495.81 h]; MECH ENG [222.26 h]; SCIENTIST [273.55 h]; ADMIN [376.13 h]; OFFICE [376.13 h]; SR STAFF [1745.16 h]; SUPPLIES & MATERIALS | 314,583.31 |  | PARKINSON J |  | 1 | 1 | CLAUS R | 09-012 | 08-032 |  |  |  |  |  |  |
| 171909LOEX |  | FY09 Constrctn Proj Office Proj Mngmnt |  | 59d | 2008-10-01 | 2008-12-24 | 1252908LOEB | 20d | 0d | OFFICE [418.71 h]; SUPPLIES & MATERIALS; DIRECTORATE [171.29 h]; ELEC ENG [837.42 h]; SCIENTIST [209.35 h]; SR STAFF [1674.84 h]; ADMIN [418.71 h] | 331,269.93 |  | PARKINSON J |  | 1 | 1 | CLAUS R |  |  | 08-058 |  |  |  |  |  |
| 1251910 |  | Re-Baseline Actuals Adjustment |  | 1d | 2013-08-30 | 2013-08-30 | 9-130M FS+227d | 20d |  | PROCUREMENT>$50K 69 NO ESCALATION | -258,656.11 |  | PARKINSON J |  | 1 | 1 | CLAUS R |  |  |  | 13-014 | ADJ |  |  |  |
|  | 2 | **1.2.5.2 PED PROJECT MANAGEMENT PROJECT OFFICE (OPM STAFF)** |  |  | 2006-10-02 | 2013-08-30 |  |  |  |  |  |  |  |  |  |  |  |  |  |  |  |  |  |  |  |
| 1252007LOE |  | FY07 Project Management Project Office |  | 247d | 2006-10-02 | 2007-09-28 | 9-070M | 20d | 0d | SR STAFF [528 h]; ADMIN [1056 h]; MECH ENG [1056 h]; SUPPLIES & MATERIALS | 216,710 | 2007-09-28 | PARKINSON J |  | 1 | 1 | CLAUS R | 09-012 |  |  |  |  |  |  |  |
| 1252010 |  | PREP for OECM EVMS Contractor Certification Review |  | 40d | 2007-09-17 | 2007-11-09 | 3R-07M | 31d | 0d |  |  |  | PARKINSON J |  | 1 | 1 | CLAUS R |  |  |  |  |  |  |  |  |
| 1252908LOE |  | FY08 PED OPM Proj Mngmnt P-1 |  | 131d | 2007-10-01 | 2008-04-15 | 122211007LOE, 1252007LOE | 20d | 0d | OFFICE [380.32 h]; ADMIN [1115.61 h]; DIRECTORATE [278.9 h]; SUPPLIES & MATERIALS; MECH ENG [1394.52 h] | 231,521.42 |  | PARKINSON J |  | 1 | 1 | CLAUS R |  | 08-032 |  |  |  |  |  |  |
| 1252015 |  | OECM EVMS Contractor Certification REVIEW |  | 5d | 2007-12-03 | 2007-12-07 | 1252010 FS+13d | 31d |  |  |  |  | PARKINSON J |  | 1 | 1 | CLAUS R |  |  |  |  |  |  |  |  |
| 1252908LOEB |  | FY08 PED OPM Proj Mngmnt P-2 |  | 117d | 2008-04-16 | 2008-09-30 | 1252908LOE | 20d | 0d |  |  |  | PARKINSON J |  | 1 | 1 | CLAUS R | 09-012 | 08-032 |  |  |  |  |  |  |
| 1252910 |  | Re-Baseline Actuals Adjustment |  | 1d | 2013-08-30 | 2013-08-30 | 9-130M FS+227d | 20d |  | PROCUREMENT>$50K 69 NO ESCALATION | -43,750.29 |  | PARKINSON J |  | 1 | 1 | CLAUS R |  |  |  | 13-014 | ADJ |  |  |  |
|  | 6 | **1.2.6 ACCELERATOR SYSTEMS COMMISSIONING PLANNING** |  |  | 2006-11-01 | 2013-08-30 |  |  |  |  |  |  |  |  |  |  |  |  |  |  |  |  |  |  |  |
| 126000M |  | Start Milestone for Commissioning PED (ACC SYS COMMIS PLNNG) | milestone | 0d | 2006-11-01 | 2006-11-01 | 9-070M FS+22d | 278d | 0d |  |  | 2006-11-01 | SPATA M |  | 1 | 1 | MIKE S |  |  |  |  |  | 6 |  |  |
| 126005 |  | Develop draft commissioning plan for EIR (ACC SYS COMMIS PLNNG) |  | 130d | 2006-11-01 | 2007-05-15 | 126000M | 278d | 0d | SCIENTIST [139.2 h] | 8,912.98 | 2007-05-15 | SPATA M |  | 1 | 1 | MIKE S |  |  |  |  |  |  |  |  |
| 126010 |  | Preliminary Design & Safety Review for Commissioning Plan (ACC SYS COMMIS PLNNG) |  | 1d | 2007-05-16 | 2007-05-16 | 126005 | 278d | 0d | SCIENTIST [354.96 h] | 22,553.9 | 2007-05-16 | SPATA M |  | 1 | 1 | MIKE S |  |  |  |  |  |  |  |  |
| 126015 |  | Post-review development of Commissioning Plan (ACC SYS COMMIS PLNNG) |  | 10d | 2007-05-17 | 2007-05-31 | 126010 | 278d | 0d | SCIENTIST [27.84 h] | 1,768.95 | 2007-05-31 | SPATA M |  | 1 | 1 | MIKE S |  |  |  |  |  |  |  |  |
| 126020M |  | Draft commissioning plan ready for EIR (ACC SYS COMMIS PLNNG) | milestone | 0d | 2007-05-31 | 2007-05-31 | 126015 | 278d | 201d |  |  | 2007-05-31 | SPATA M |  | 1 | 1 | MIKE S |  |  |  |  |  | 5 |  |  |
| 126025M |  | Start of FY08 Commssng Planning (ACC SYS COMMIS PLNNG) | milestone | 0d | 2008-03-27 | 2008-03-27 | 126020M, 9-080M FS+117d | 77d | 0d |  |  |  | SPATA M |  | 1 | 1 | MIKE S |  |  |  |  |  | 6 | 07-027 |  |
| 126030 |  | Development of Sys's Cmmssng Milestones (ACC SYS COMMIS PLNNG) |  | 130d | 2008-03-27 | 2008-09-29 | 126025M | 77d | 0d | MECH ENG [20 h]; COMP SCIENT [80 h]; ELEC ENG [20 h]; ADMIN [80 h]; SCIENTIST [240 h] | 26,200 |  | SPATA M |  | 1 | 1 | MIKE S |  |  |  |  |  |  | 07-027 |  |
| 126035M |  | Comp Draft Sys's Cmmssng Milestones (ACC SYS COMMIS PLNNG) | milestone | 0d | 2008-09-29 | 2008-09-29 | 126030 | 77d | 0d |  |  |  | SPATA M |  | 1 | 1 | MIKE S |  |  |  |  |  | 6 | 07-027 |  |
| 126040 |  | Review of Sys Milestones with Sys owners (ACC SYS COMMIS PLNNG) |  | 1d | 2008-09-30 | 2008-09-30 | 126035M | 77d | 0d | MECH ENG [20 h]; ADMIN [20 h]; SCIENTIST [20 h]; ELEC ENG [20 h] | 4,763 |  | SPATA M |  | 1 | 1 | MIKE S |  |  |  |  |  |  | 07-027 |  |
| 126045 |  | Incorporate Changes from Review of Sys's Milestones (ACC SYS COMMIS PLNNG) |  | 20d | 2008-10-01 | 2008-10-28 | 126040 | 77d | 0d | SCIENTIST [120 h]; ADMIN [40 h] | 9,849.2 |  | SPATA M |  | 1 | 1 | MIKE S |  |  |  |  |  |  | 07-027 |  |
| 126060 |  | Development of Beam-Based Cmmssng Plan (ACC SYS COMMIS PLNNG) |  | 130d | 2008-10-29 | 2009-05-12 | 126045 | 77d | 0d | SCIENTIST [480 h]; ADMIN [200 h] | 41,534.8 |  | SPATA M |  | 1 | 1 | MIKE S |  |  |  |  |  |  | 07-027 | FY08-09 |
| 126065M |  | Comp Draft Beam-Based Commssng Plan (ACC SYS COMMIS PLNNG) | milestone | 0d | 2009-05-12 | 2009-05-12 | 126060 | 77d | 0d |  |  |  | SPATA M |  | 1 | 1 | MIKE S |  |  |  |  |  | 6 | 07-027 |  |
| 126070 |  | Review of Beam-Based Cmmssng Plan (ACC SYS COMMIS PLNNG) |  | 1d | 2009-05-13 | 2009-05-13 | 126065M | 77d | 0d | ELEC ENG [4 h]; SCIENTIST [20 h]; MECH ENG [4 h]; ADMIN [4 h] | 2,011.16 |  | SPATA M |  | 1 | 1 | MIKE S |  |  |  |  |  |  | 07-027 |  |
| 126075 |  | Incorporate Changes from Review of Beam-Based Plan (ACC SYS COMMIS PLNNG) |  | 20d | 2009-05-14 | 2009-06-11 | 126070 | 77d | 0d | ADMIN [40 h]; SCIENTIST [120 h] | 9,849.2 |  | SPATA M |  | 1 | 1 | MIKE S |  |  |  |  |  |  | 07-027 |  |
| 126080M |  | Comp Commssng Plan (ACC SYS COMMIS PLNNG) | milestone | 0d | 2009-06-11 | 2009-06-11 | 126075 | 77d |  |  |  |  | SPATA M |  | 1 | 1 | MIKE S |  |  |  |  |  | 6 | 07-027 |  |
| 126085 |  | Re-Baseline Actuals Adjustment |  | 1d | 2013-08-30 | 2013-08-30 | 9-130M FS+227d | 20d |  | PROCUREMENT>$50K 69 NO ESCALATION | -69,124.86 |  | SPATA M |  | 1 | 1 | MIKE S |  |  |  | 13-014 | ADJ |  |  |  |

| ID | WBS | Activity | Duration | Start | Finish | Predecessors | Total float | Free float | Resources | Cost | RESP - Responsibility | STRT%COMP for CM EVM | FNSH%COMP for CM EVM | CAM RESPONSIBLE | CR 08-050 | CR 10-027 | CR 10-064 | CR 11-051 | CR 12-018 | Advance Purchase Plan > 500K | 12 GEV MAJOR PROCUREMENT CATAGORY | CR 09-032 | CR 09-032 Repair | CR 09-012 | CR 07-027 | CR 08-016 | CR 10-001 | CR 09-037 | CR 10-043 | CR 13-014 | ReBaseline Actuals Adjustment | CR 09-039 | CR 10-023 | CR 11-003 | CR 11-012 | CR 09-017 | CR 07-024 | CR 11-001 |
| --- | --- | --- | --- | --- | --- | --- | --- | --- | --- | --- | --- | --- | --- | --- | --- | --- | --- | --- | --- | --- | --- | --- | --- | --- | --- | --- | --- | --- | --- | --- | --- | --- | --- | --- | --- | --- | --- | --- |
|  | 3 | **1.3 CONSTRUCTION ACCELERATOR SYSTEMS** |  | 2009-01-02 | 2014-10-31 |  |  |  |  |  |  |  |  |  |  |  |  |  |  |  |  |  |  |  |  |  |  |  |  |  |  |  |  |  |  |  |  |  |
|  | 1 | **1.3.1 CRYOMODULES** |  | 2009-01-02 | 2013-08-30 |  |  |  |  |  |  |  |  |  |  |  |  |  |  |  |  |  |  |  |  |  |  |  |  |  |  |  |  |  |  |  |  |  |
|  | 1 | **1.3.1.1 PROCUREMENTS** |  | 2009-01-02 | 2013-08-30 |  |  |  |  |  |  |  |  |  |  |  |  |  |  |  |  |  |  |  |  |  |  |  |  |  |  |  |  |  |  |  |  |  |
|  | 1 | **1.3.1.1.1 CAVITY STRING PROCUREMENTS** |  | 2009-01-05 | 2013-08-30 |  |  |  |  |  |  |  |  |  |  |  |  |  |  |  |  |  |  |  |  |  |  |  |  |  |  |  |  |  |  |  |  |  |
|  | 1 | **1.3.1.1.1.1 NIOBIUM** |  | 2009-01-05 | 2013-08-30 |  |  |  |  |  |  |  |  |  |  |  |  |  |  |  |  |  |  |  |  |  |  |  |  |  |  |  |  |  |  |  |  |  |
| 131111010 |  | Proc Niobium | 1d | 2009-01-05 | 2009-01-05 | 9-090M FS+60d | 527d | 0d | MECH ENG [8 h]; SCIENTIST [8 h]; MECH DES [40 h] | 2,778.16 | HOGAN J | 1 | 1 | JOHN H | 08-050 | 10-027 | 10-064 | 11-051 | 12-018F |  |  |  |  |  |  |  |  |  |  |  |  |  |  |  |  |  |  |  |
| 131111011 |  | Niobium Labor and Expenses Initial | 101d | 2009-01-06 | 2009-05-29 | 131111010 | 527d | 0d | TRAVEL; MECH DES [100 h]; ELEC ENG [60 h]; MECH ENG [100 h]; SR STAFF [100 h]; SCIENTIST [24 h]; SUPPLIES & MATERIALS | 28,932.43 | HOGAN J | 1 | 1 | JOHN H | 08-050 | 10-027 | 10-064 | 11-051 | 12-018F | APP | 3111B | 09-032 | 09-032 |  |  |  |  |  |  |  |  |  |  |  |  |  |  |  |
| 131111012 |  | Expenses Niobium Batch 1 | 101d | 2009-01-06 | 2009-05-29 | 131111010 | 713d | 583d | SUPPLIES & MATERIALS; TRAVEL | 2,294.62 | HOGAN J | 1 | 1 | JOHN H | 08-050 | 10-027 | 10-064 | 11-051 | 12-018F | APP | 3111B | 09-032 | 09-032 | 09-012 |  |  |  |  |  |  |  |  |  |  |  |  |  |  |
| 131111013 |  | Expenses Niobium Batch 2 | 101d | 2009-01-06 | 2009-05-29 | 131111010 | 713d | 583d | SUPPLIES & MATERIALS; TRAVEL | 2,294.62 | HOGAN J | 1 | 1 | JOHN H | 08-050 | 10-027 | 10-064 | 11-051 | 12-018F | APP | 3111B | 09-032 | 09-032 | 09-012 | 07-027 | 08-016 |  |  |  |  |  |  |  |  |  |  |  |  |
| 131111011LOE |  | Niobium Labor and Expenses Final FY09 | 55d | 2009-07-15 | 2009-09-30 | 131111011 FS+31d | 527d | 0d | MECH DES [8.52 h]; TRAVEL; ELEC ENG [5.68 h]; MECH ENG [8.52 h]; SR STAFF [7.81 h]; SCIENTIST [3.55 h]; SUPPLIES & MATERIALS | 2,827.53 | HOGAN J | 1 | 1 | JOHN H | 08-050 | 10-027 | 10-064 | 11-051 | 12-018F | APP | 3111B | 09-032 | 09-032 |  |  |  | 10-001B |  |  |  |  |  |  |  |  |  |  |  |
| 131111012A |  | Vend Fab - Order Niobium | 19d | 2009-07-15 | 2009-08-10 | 9-090M FS+193d | 663d | 533d | PROCUREMENT<$50K 60; PROCUREMENT>$50K 69 | 355,042.38 | HOGAN J | 1 | 1 | JOHN H | 08-050 | 10-027 | 10-064 | 11-051 | 12-018F | APP | 3111B | 09-032 | 09-032 |  |  |  |  | 09-037 |  |  |  |  |  |  |  |  |  |  |
| 131111012B |  | Vend Fab - Niobium Batch 1 | 85d | 2009-07-15 | 2009-11-11 | 9-090M FS+193d | 577d | 0d | PROCUREMENT>$50K 69 NO ESCALATION | 634,004.25 | HOGAN J | 1 | 1 | JOHN H | 08-050 | 10-027 | 10-064 | 11-051 | 12-018F | APP | 3111B | 09-032 | 09-032 | 09-012 |  |  | 10-001A | 09-037 |  |  |  |  |  |  |  |  |  |  |
| 131111013A |  | Vend Fab - Niobium Batch 2 | 142d | 2009-07-15 | 2010-02-11 | 9-090M FS+193d | 530d | 0d | PROCUREMENT>$50K 69 NO ESCALATION | 1,546,970.37 | HOGAN J | 1 | 1 | JOHN H | 08-050 | 10-027 | 10-064 | 11-051 | 12-018F | APP | 3111B | 09-032 | 09-032 | 09-012 | 07-027 | 08-016 | 10-001A | 09-037 |  |  |  |  |  |  |  |  |  |  |
| 131111011LOEb |  | Niobium Labor and Expenses Final FY10 | 100d | 2009-10-01 | 2010-03-03 | 131111011LOE | 527d | 397d | TRAVEL; SR STAFF [14.19 h]; SCIENTIST [6.45 h]; ELEC ENG [10.32 h]; MECH ENG [15.48 h]; SUPPLIES & MATERIALS; MECH DES [15.48 h] | 5,301.92 | HOGAN J | 1 | 1 | JOHN H |  | 10-027 | 10-064 | 11-051 | 12-018F | APP | 3111B |  |  |  |  |  | 10-001B |  |  |  |  |  |  |  |  |  |  |  |
| 131111015 |  | Receive & Insp Niobium Batch 1 | 20d | 2009-11-12 | 2009-12-11 | 131111012B | 577d | 447d | SUPPLIES & MATERIALS; MECH TECH [240 h]; ELEC ENG [80 h]; COMP SCIENT [120 h]; MECH DES [80 h]; MECH ENG [80 h]; SCIENTIST [40 h]; SR STAFF [200 h] | 60,015.19 | HOGAN J | 1 | 1 | JOHN H | 08-050 | 10-027 | 10-064 | 11-051 | 12-018F |  |  | 09-032 | 09-032 |  |  |  |  |  |  |  |  |  |  |  |  |  |  |  |
| 131111020 |  | Receive & Insp Niobium Batch 2 (Original History) | 10d | 2010-02-12 | 2010-02-26 | 131111013A | 530d | 400d | SUPPLIES & MATERIALS; ELEC ENG [80 h]; MECH DES [20 h]; MECH TECH [240 h]; MECH ENG [40 h] | 20,258.95 | HOGAN J | 1 | 1 | JOHN H | 08-050 | 10-027 | 10-064 | 11-051 | 12-018F |  |  | 09-032 | 09-032 |  |  |  |  |  | 10-043 |  |  |  |  |  |  |  |  |  |
| 131111013B |  | Vend Fab - Niobium Batch 2 Reverse Entry per CR 10-043 | 1d | 2010-03-01 | 2010-03-01 | 9-100M FS+97d | 528d | 0d | PROCUREMENT>$50K 69 NO ESCALATION | -1,546,970.37 | HOGAN J | 1 | 1 | JOHN H |  |  | 10-064 | 11-051 | 12-018F | APP | 3111B |  |  |  |  |  |  |  | 10-043 |  |  |  |  |  |  |  |  |  |
| 131111013C |  | Vend Fab - Niobium Batch 2 Revised Delivery per CR 10-043 | 151d | 2010-03-01 | 2010-09-30 | 9-100M FS+97d | 379d | 0d | PROCUREMENT>$50K 69 NO ESCALATION | 1,546,970.37 | HOGAN J | 1 | 1 | JOHN H |  |  | 10-064 | 11-051 | 12-018F | APP | 3111B |  |  |  |  |  |  |  | 10-043 |  |  |  |  |  |  |  |  |  |
| 131111020A |  | Receive & Insp Niobium Batch 2 Reverse Entry per CR 10-043 | 1d | 2010-03-02 | 2010-03-02 | 9-100M FS+97d, 131111013B | 528d | 398d | MECH TECH [-240 h]; MECH ENG [-40 h]; SUPPLIES & MATERIALS; ELEC ENG [-80 h]; MECH DES [-20 h] | -20,258.95 | HOGAN J | 1 | 1 | JOHN H |  |  | 10-064 | 11-051 | 12-018F |  |  |  |  |  |  |  |  |  | 10-043 |  |  |  |  |  |  |  |  |  |
| 131111020B |  | Receive & Insp Niobium Batch 2 Revised Delivery per CR 10-043 | 10d | 2010-09-17 | 2010-09-30 | 131111013C FS-10d | 379d | 249d | ELEC ENG [160 h]; MECH DES [40 h]; MECH TECH [480 h]; MECH ENG [80 h]; SUPPLIES & MATERIALS | 40,517.9 | HOGAN J | 1 | 1 | JOHN H |  |  | 10-064 | 11-051 | 12-018F |  |  |  |  |  |  |  |  |  | 10-043 |  |  |  |  |  |  |  |  |  |
| 131111025 |  | Re-Baseline Actuals Adjustment | 1d | 2013-08-30 | 2013-08-30 | 9-130M FS+227d | 20d |  | PROCUREMENT>$50K 69 NO ESCALATION | 62,672.03 | HOGAN J | 1 | 1 | JOHN H |  |  |  |  |  |  |  |  |  |  |  |  |  |  |  | 13-014 | ADJ |  |  |  |  |  |  |  |
|  | 2 | **1.3.1.1.1.2 CAVITY FABRICATION** |  | 2009-01-05 | 2013-08-30 |  |  |  |  |  |  |  |  |  |  |  |  |  |  |  |  |  |  |  |  |  |  |  |  |  |  |  |  |  |  |  |  |  |
| 131112000 |  | Re-Baseline Actuals Adjustment | 1d | 2013-08-30 | 2013-08-30 | 9-130M FS+227d | 20d |  | PROCUREMENT>$50K 69 NO ESCALATION | 21,000.2 | HOGAN J | 1 | 1 | JOHN H |  |  |  |  |  |  |  |  |  |  |  |  |  |  |  | 13-014 | ADJ |  |  |  |  |  |  |  |
|  | 1 | **1.3.1.1.1.2.1 VEND FAB CAVITIES** |  | 2009-01-05 | 2011-09-22 |  |  |  |  |  |  |  |  |  |  |  |  |  |  |  |  |  |  |  |  |  |  |  |  |  |  |  |  |  |  |  |  |  |
| 1311121010 |  | Proc Cavity Fab | 5d | 2009-01-05 | 2009-01-09 | 9-090M FS+60d, 121113005 | 169d | 0d | MECH DES [40 h]; MECH ENG [40 h] | 4,306 | HOGAN J | 1 | 1 | JOHN H | 08-050 | 10-027 | 10-064 | 11-051 | 12-018F |  |  |  |  |  |  |  |  |  |  |  |  |  |  |  |  |  |  |  |
| 1311121015 |  | Cavities Labor Initial | 97d | 2009-01-12 | 2009-05-29 | 1311121010 | 169d | 0d | ELEC ENG [61.6 h]; MECH ENG [70 h]; SCIENTIST [50 h]; SR STAFF [50 h]; MECH DES [70.4 h] | 19,864.61 | HOGAN J | 1 | 1 | JOHN H | 08-050 | 10-027 | 10-064 | 11-051 | 12-018F | APP | 3111C | 09-032 | 09-032 | 09-012 |  | 08-016 |  |  |  |  |  |  |  |  |  |  |  |  |
| 1311121015LOE |  | Cavities Labor Final FY09 | 55d | 2009-07-15 | 2009-09-30 | 1311121015 FS+31d | 169d | 0d | MECH DES [9.53 h]; ELEC ENG [2.02 h]; MECH ENG [9.69 h]; SCIENTIST [3.26 h]; SR STAFF [7.46 h] | 2,142.54 | HOGAN J | 1 | 1 | JOHN H | 08-050 | 10-027 | 10-064 | 11-051 | 12-018F | APP | 3111C | 09-032 | 09-032 | 09-012 |  | 08-016 | 10-001B |  |  |  |  |  |  |  |  |  |  |  |
| 1311121016 |  | Vend Fab Cavities 1 & 2 | 239d | 2009-07-15 | 2010-06-30 | 9-090M FS+193d | 53d | 0d | PROCUREMENT>$50K 69 NO ESCALATION | 83,288 | HOGAN J | 1 | 1 | JOHN H | 08-050 | 10-027 | 10-064 | 11-051 |  | APP | 3111C | 09-032 | 09-032 | 09-012 |  | 08-016 |  | 09-037 | 10-043 |  |  | 09-039 | 10-023 | 11-003 | 11-012 |  |  |  |
| 1311121020 |  | Vend Fab Cavities 3 thru 8 | 260d | 2009-07-15 | 2010-07-30 | 9-090M FS+193d | 40d | 0d | PROCUREMENT>$50K 69 NO ESCALATION | 249,864 | HOGAN J | 1 | 1 | JOHN H | 08-050 | 10-027 | 10-064 | 11-051 |  | APP | 3111C | 09-032 | 09-032 |  |  |  |  | 09-037 |  |  |  | 09-039 | 10-023 | 11-003 | 11-012 | 09-017 |  |  |
| 1311121025 |  | Vend Fab Cavities 9 thru 14 | 260d | 2009-07-15 | 2010-07-30 | 9-090M FS+193d | 80d | 43d | PROCUREMENT>$50K 69 NO ESCALATION | 249,864 | HOGAN J | 1 | 1 | JOHN H | 08-050 | 10-027 | 10-064 | 11-051 |  | APP | 3111C | 09-032 | 09-032 |  |  |  |  | 09-037 |  |  |  | 09-039 | 10-023 | 11-003 | 11-012 | 09-017 |  |  |
| 1311121030 |  | Vend Fab Cavities 15 thru 20 | 282d | 2009-07-15 | 2010-08-31 | 9-090M FS+193d | 73d | 36d | PROCUREMENT>$50K 69 NO ESCALATION | 249,864 | HOGAN J | 1 | 1 | JOHN H | 08-050 | 10-027 | 10-064 | 11-051 |  | APP | 3111C | 09-032 | 09-032 |  |  |  |  | 09-037 |  |  |  | 09-039 | 10-023 | 11-003 | 11-012 | 09-017 |  |  |
| 1311121035 |  | Vend Fab Cavities 21 thru 26 | 303d | 2009-07-15 | 2010-09-30 | 9-090M FS+193d | 138d | 31d | PROCUREMENT>$50K 69 NO ESCALATION | 249,864 | HOGAN J | 1 | 1 | JOHN H | 08-050 | 10-027 | 10-064 | 11-051 | 12-018F | APP | 3111C | 09-032 | 09-032 |  |  |  |  |  |  |  |  | 09-039 | 10-023 |  | 11-012 | 09-017 |  |  |
| 1311121040 |  | Vend Fab Cavities 27 thru 32 | 324d | 2009-07-15 | 2010-10-29 | 9-090M FS+193d | 134d | 26d | PROCUREMENT>$50K 69 NO ESCALATION | 249,864 | HOGAN J | 1 | 1 | JOHN H | 08-050 | 10-027 | 10-064 | 11-051 | 12-018F | APP | 3111C | 09-032 | 09-032 |  |  |  |  |  |  |  |  | 09-039 | 10-023 | 11-003 | 11-012 | 09-017 |  |  |
| 1311121045 |  | Vend Fab Cavities 33 thru 38 | 361d | 2009-07-15 | 2010-12-30 | 9-090M FS+193d | 130d | 22d | PROCUREMENT>$50K 69 NO ESCALATION | 249,864 | HOGAN J | 1 | 1 | JOHN H | 08-050 | 10-027 | 10-064 | 11-051 | 12-018F | APP | 3111C | 09-032 | 09-032 |  |  |  |  |  |  |  |  | 09-039 | 10-023 | 11-003 | 11-012 | 09-017 |  |  |
| 1311121050 |  | Vend Fab Cavities 39 thru 44 | 381d | 2009-07-15 | 2011-01-31 | 9-090M FS+193d | 129d | 21d | PROCUREMENT>$50K 69 NO ESCALATION | 249,864 | HOGAN J | 1 | 1 | JOHN H | 08-050 | 10-027 | 10-064 | 11-051 | 12-018F | APP | 3111C | 09-032 | 09-032 |  |  |  |  |  |  |  |  | 09-039 | 10-023 | 11-003 | 11-012 | 09-017 |  |  |
| 1311121055 |  | Vend Fab Cavities 45 thru 50 | 400d | 2009-07-15 | 2011-02-28 | 9-090M FS+193d | 109d | 0d | PROCUREMENT>$50K 69 NO ESCALATION | 249,864 | HOGAN J | 1 | 1 | JOHN H | 08-050 | 10-027 |  | 11-051 | 12-018F | APP | 3111C | 09-032 | 09-032 |  |  |  |  |  |  |  |  | 09-039 | 10-023 | 11-003 | 11-012 | 09-017 |  |  |
| 1311121060 |  | Vend Fab Cavities 51 thru 56 | 423d | 2009-07-15 | 2011-03-31 | 9-090M FS+193d | 111d | 0d | PROCUREMENT>$50K 69 NO ESCALATION | 249,864 | HOGAN J | 1 | 1 | JOHN H | 08-050 | 10-027 | 10-064 | 11-051 | 12-018F | APP | 3111C | 09-032 | 09-032 |  |  |  |  |  |  |  |  | 09-039 | 10-023 | 11-003 | 11-012 | 09-017 |  |  |
| 1311121065 |  | Vend Fab Cavities 57 thru 62 | 444d | 2009-07-15 | 2011-04-29 | 9-090M FS+193d | 110d | 0d | PROCUREMENT>$50K 69 NO ESCALATION | 249,864 | HOGAN J | 1 | 1 | JOHN H | 08-050 | 10-027 | 10-064 | 11-051 | 12-018F | APP | 3111C | 09-032 | 09-032 |  | 07-027 |  |  |  |  |  |  | 09-039 | 10-023 | 11-003 | 11-012 | 09-017 | 07-024 |  |
| 1311121070 |  | Vend Fab Cavities 63 thru 68 | 465d | 2009-07-15 | 2011-05-31 | 9-090M FS+193d | 105d | 0d | PROCUREMENT>$50K 69 NO ESCALATION | 249,864 | HOGAN J | 1 | 1 | JOHN H | 08-050 | 10-027 | 10-064 | 11-051 | 12-018F | APP | 3111C | 09-032 | 09-032 |  |  |  |  |  |  |  |  | 09-039 | 10-023 | 11-003 | 11-012 | 09-017 |  |  |
| 1311121075 |  | Vend Fab Cavities 69 thru 74 | 487d | 2009-07-15 | 2011-06-30 | 9-090M FS+193d | 123d | 25d | PROCUREMENT>$50K 69 NO ESCALATION | 249,864 | HOGAN J | 1 | 1 | JOHN H | 08-050 | 10-027 | 10-064 | 11-051 | 12-018F | APP | 3111C | 09-032 | 09-032 |  |  |  |  |  |  |  |  | 09-039 | 10-023 | 11-003 |  | 09-017 |  |  |
| 1311121080 |  | Vend Fab Cavities 75 thru 80 | 507d | 2009-07-15 | 2011-07-29 | 9-090M FS+193d | 119d | 21d | PROCUREMENT>$50K 69 NO ESCALATION | 249,864 | HOGAN J | 1 | 1 | JOHN H | 08-050 | 10-027 | 10-064 | 11-051 | 12-018F | APP | 3111C | 09-032 | 09-032 |  | 07-027 |  |  |  |  |  |  | 09-039 | 10-023 | 11-003 |  | 09-017 | 07-024 |  |
| 1311121085 |  | Vend Fab Cavities 81 thru 86 | 530d | 2009-07-15 | 2011-08-31 | 9-090M FS+193d | 111d | 13d | PROCUREMENT>$50K 69 NO ESCALATION | 249,864 | HOGAN J | 1 | 1 | JOHN H | 08-050 | 10-027 | 10-064 | 11-051 | 12-018F | APP | 3111C | 09-032 | 09-032 |  | 07-027 |  |  |  |  |  |  | 09-039 | 10-023 | 11-003 |  | 09-017 | 07-024 |  |
| 1311121015LOEb |  | Cavities Labor Final FY10 | 248d | 2009-10-01 | 2010-09-30 | 1311121015LOE | 169d | 0d | MECH ENG [43.7 h]; MECH DES [42.98 h]; SCIENTIST [14.7 h]; SR STAFF [33.65 h]; ELEC ENG [9.09 h] | 9,970.16 | HOGAN J | 1 | 1 | JOHN H |  | 10-027 | 10-064 | 11-051 | 12-018F | APP | 3111C |  |  |  |  |  | 10-001B |  |  |  |  |  |  |  |  |  |  | 11-001 |
| 1311121017 |  | Vend Fab Chemistry & Tuning Cavities 1 & 2 | 125d | 2010-01-04 | 2010-06-30 | 9-100M FS+59d | 53d | 0d | PROCUREMENT<$50K 60 NO ESCALATION | 17,441.56 | HOGAN J | 1 | 1 | JOHN H |  | 10-027 | 10-064 | 11-051 |  | APP | 3111C |  |  |  |  |  |  |  | 10-043 |  |  | 09-039 | 10-023 | 11-003 | 11-012 |  |  |  |
| 1311121021 |  | Vend Fab Chemistry & Tuning Cavities 3 thru 8 | 146d | 2010-01-04 | 2010-07-30 | 9-100M FS+59d | 40d | 0d | PROCUREMENT>$50K 69 NO ESCALATION; PROCUREMENT<$50K 60 NO ESCALATION | 52,324.67 | HOGAN J | 1 | 1 | JOHN H |  | 10-027 | 10-064 | 11-051 |  | APP | 3111C |  |  |  |  |  |  |  |  |  |  | 09-039 | 10-023 | 11-003 | 11-012 |  |  |  |
| 1311121026 |  | Vend Fab Chemistry & Tuning Cavities 9 thru 14 | 146d | 2010-01-04 | 2010-07-30 | 9-100M FS+59d | 80d | 43d | PROCUREMENT>$50K 69 NO ESCALATION | 52,324.67 | HOGAN J | 1 | 1 | JOHN H |  | 10-027 | 10-064 | 11-051 |  | APP | 3111C |  |  |  |  |  |  |  |  |  |  | 09-039 | 10-023 | 11-003 | 11-012 |  |  |  |
| 1311121031 |  | Vend Fab Chemistry & Tuning Cavities 15 thru 20 | 168d | 2010-01-04 | 2010-08-31 | 9-100M FS+59d | 73d | 36d | PROCUREMENT>$50K 69 NO ESCALATION | 52,324.67 | HOGAN J | 1 | 1 | JOHN H |  | 10-027 | 10-064 | 11-051 |  | APP | 3111C |  |  |  |  |  |  |  |  |  |  | 09-039 | 10-023 | 11-003 | 11-012 |  |  |  |
| 1311121036 |  | Vend Fab Chemistry & Tuning Cavities 21 thru 26 | 189d | 2010-01-04 | 2010-09-30 | 9-100M FS+59d | 138d | 31d | PROCUREMENT>$50K 69 NO ESCALATION | 52,324.67 | HOGAN J | 1 | 1 | JOHN H |  | 10-027 | 10-064 | 11-051 | 12-018F | APP | 3111C |  |  |  |  |  |  |  |  |  |  | 09-039 | 10-023 |  | 11-012 |  |  |  |
| 1311121041 |  | Vend Fab Chemistry & Tuning Cavities 27 thru 32 | 210d | 2010-01-04 | 2010-10-29 | 9-100M FS+59d | 134d | 26d | PROCUREMENT>$50K 69 NO ESCALATION | 52,324.67 | HOGAN J | 1 | 1 | JOHN H |  | 10-027 | 10-064 | 11-051 | 12-018F | APP | 3111C |  |  |  |  |  |  |  |  |  |  | 09-039 | 10-023 | 11-003 | 11-012 |  |  |  |
| 1311121046 |  | Vend Fab Chemistry & Tuning Cavities 33 thru 38 | 247d | 2010-01-04 | 2010-12-30 | 9-100M FS+59d | 130d | 22d | PROCUREMENT>$50K 69 NO ESCALATION | 52,324.67 | HOGAN J | 1 | 1 | JOHN H |  | 10-027 | 10-064 | 11-051 | 12-018F | APP | 3111C |  |  |  |  |  |  |  |  |  |  | 09-039 | 10-023 | 11-003 | 11-012 |  |  |  |
| 1311121051 |  | Vend Fab Chemistry & Tuning Cavities 39 thru 44 | 267d | 2010-01-04 | 2011-01-31 | 9-100M FS+59d | 129d | 21d | PROCUREMENT>$50K 69 NO ESCALATION | 52,324.67 | HOGAN J | 1 | 1 | JOHN H |  | 10-027 | 10-064 | 11-051 | 12-018F | APP | 3111C |  |  |  |  |  |  |  |  |  |  | 09-039 | 10-023 | 11-003 | 11-012 |  |  |  |
| 1311121056 |  | Vend Fab Chemistry & Tuning Cavities 45 thru 50 | 286d | 2010-01-04 | 2011-02-28 | 9-100M FS+59d | 109d | 0d | PROCUREMENT>$50K 69 NO ESCALATION | 52,324.67 | HOGAN J | 1 | 1 | JOHN H |  | 10-027 |  | 11-051 | 12-018F | APP | 3111C |  |  |  |  |  |  |  |  |  |  | 09-039 | 10-023 | 11-003 | 11-012 |  |  |  |
| 1311121061 |  | Vend Fab Chemistry & Tuning Cavities 51 thru 56 | 309d | 2010-01-04 | 2011-03-31 | 9-100M FS+59d | 111d | 0d | PROCUREMENT>$50K 69 NO ESCALATION | 52,324.67 | HOGAN J | 1 | 1 | JOHN H |  | 10-027 | 10-064 | 11-051 | 12-018F | APP | 3111C |  |  |  |  |  |  |  |  |  |  | 09-039 | 10-023 | 11-003 | 11-012 |  |  |  |
| 1311121066 |  | Vend Fab Chemistry & Tuning Cavities 57 thru 62 | 330d | 2010-01-04 | 2011-04-29 | 9-100M FS+59d | 110d | 0d | PROCUREMENT>$50K 69 NO ESCALATION | 52,324.67 | HOGAN J | 1 | 1 | JOHN H |  | 10-027 | 10-064 | 11-051 | 12-018F | APP | 3111C |  |  |  |  |  |  |  |  |  |  | 09-039 | 10-023 | 11-003 | 11-012 |  |  |  |
| 1311121071 |  | Vend Fab Chemistry & Tuning Cavities 63 thru 68 | 351d | 2010-01-04 | 2011-05-31 | 9-100M FS+59d | 105d | 0d | PROCUREMENT>$50K 69 NO ESCALATION | 52,324.67 | HOGAN J | 1 | 1 | JOHN H |  | 10-027 | 10-064 | 11-051 | 12-018F | APP | 3111C |  |  |  |  |  |  |  |  |  |  | 09-039 | 10-023 | 11-003 | 11-012 |  |  |  |
| 1311121076 |  | Vend Fab Chemistry & Tuning Cavities 69 thru 74 | 373d | 2010-01-04 | 2011-06-30 | 9-100M FS+59d | 123d | 25d | PROCUREMENT>$50K 69 NO ESCALATION | 52,324.67 | HOGAN J | 1 | 1 | JOHN H |  | 10-027 | 10-064 | 11-051 | 12-018F | APP | 3111C |  |  |  |  |  |  |  |  |  |  | 09-039 | 10-023 | 11-003 |  |  |  |  |
| 1311121081 |  | Vend Fab Chemistry & Tuning Cavities 75 thru 80 | 393d | 2010-01-04 | 2011-07-29 | 9-100M FS+59d | 119d | 21d | PROCUREMENT>$50K 69 NO ESCALATION | 52,324.67 | HOGAN J | 1 | 1 | JOHN H |  | 10-027 | 10-064 | 11-051 | 12-018F | APP | 3111C |  |  |  |  |  |  |  |  |  |  | 09-039 | 10-023 | 11-003 |  |  |  |  |
| 1311121086 |  | Vend Fab Chemistry & Tuning Cavities 81 thru 86 | 416d | 2010-01-04 | 2011-08-31 | 9-100M FS+59d | 111d | 13d | PROCUREMENT>$50K 69 NO ESCALATION | 52,324.67 | HOGAN J | 1 | 1 | JOHN H |  | 10-027 | 10-064 | 11-051 | 12-018F | APP | 3111C |  |  |  |  |  |  |  |  |  |  | 09-039 | 10-023 | 11-003 |  |  |  |  |
| 1311121091 |  | Cavities Custom Duty Adjustment | 291d | 2010-07-01 | 2011-08-31 | 9-100M FS+184d | 105d | 7d | PROCUREMENT>$50K 69 NO ESCALATION | 50,000 | HOGAN J | 1 | 1 | JOHN H |  | 10-027 | 10-064 | 11-051 | 12-018F | APP | 3111C |  |  |  |  |  |  |  |  |  |  | 09-039 | 10-023 | 11-003 |  |  |  |  |
| 1311121096LOE |  | SOTR Oversight FY10 | 64d | 2010-07-01 | 2010-09-30 | 9-100M FS+184d | 137d | 0d | SCIENTIST [104 h] | 6,896.24 | HOGAN J | 1 | 1 | JOHN H |  | 10-027 | 10-064 | 11-051 | 12-018F | APP | 3111C |  |  |  |  |  |  |  |  |  |  | 09-039 | 10-023 |  |  |  |  |  |
| 1311121015LOEc |  | Cavities Labor Final FY11 | 210d | 2010-10-01 | 2011-08-08 | 1311121015LOEb | 169d | 39d | ELEC ENG [7.69 h]; MECH ENG [37.01 h]; SCIENTIST [12.44 h]; SR STAFF [28.49 h]; MECH DES [36.39 h] | 8,710.57 | HOGAN J | 1 | 1 | JOHN H |  | 10-027 | 10-064 | 11-051 | 12-018F | APP | 3111C |  |  |  |  |  | 10-001B |  |  |  |  |  |  |  |  |  |  | 11-001 |
| 1311121101LOE |  | SOTR Oversight FY11 | 242d | 2010-10-01 | 2011-09-22 | 1311121096LOE | 137d | 7d | SCIENTIST [400 h] | 27,372 | HOGAN J | 1 | 1 | JOHN H |  | 10-027 | 10-064 | 11-051 | 12-018F | APP | 3111C |  |  |  |  |  |  |  |  |  |  | 09-039 | 10-023 |  |  |  |  |  |

Notes:
- 1311121035: Steps: Receive and Inspect #1 thru #8; Recieve and Inspect #9 thru #16; Recieve and Inspect #17 thru #20

| ID | WBS | Activity | Type | Duration | Start | Finish | Predecessors | Total float | Free float | Resources | Cost | RESP - Responsibility | STRT%COMP for CM EVM | FNSH%COMP for CM EVM | Advance Purchase Plan > 500K | CAM RESPONSIBLE | CR 08-050 | 12 GEV MAJOR PROCUREMENT CATAGORY | CR 09-017 | CR 09-032 | CR 09-032 Repair | CR 10-023 | CR 10-027 | CR 10-043 | CR 10-064 | CR 11-003 | CR 11-012 | CR 11-051 | CR 12-018 | CR 12-001 | CR 07-024 | CR 07-027 |
| --- | --- | --- | --- | --- | --- | --- | --- | --- | --- | --- | --- | --- | --- | --- | --- | --- | --- | --- | --- | --- | --- | --- | --- | --- | --- | --- | --- | --- | --- | --- | --- | --- |
|  | 2 | **1.3.1.1.1.2.2 RECEIVE AND INSPECT CAVITIES** |  |  | 2010-06-11 | 2011-10-03 |  |  |  |  |  |  |  |  |  |  |  |  |  |  |  |  |  |  |  |  |  |  |  |  |  |  |
| 1311122005 |  | Receive and Inspect Cavities 1 & 2 |  | 10d | 2010-06-11 | 2010-06-24 | 1311121016 FS-14d, 1311121017 FS-14d | 53d | 13d | MECH ENG [46.7 h]; SR STAFF [15 h]; SUPPLIES & MATERIALS; COMP SCIENT [30 h]; ELEC TECH [30 h]; ELEC ENG [40 h]; MECH DES [30 h]; MECH TECH [60.13 h]; SCIENTIST [20 h] | 16,118.56 | HOGAN J | 1 | 1 | APP | JOHN H | 08-050 | 3111C | 09-017 | 09-032 | 09-032 | 10-023 | 10-027 | 10-043 | 10-064 | 11-003 | 11-012 | 11-051 |  |  |  |  |
| 1311122010 |  | Receive and Inspect Cavities 3 Thru 8 |  | 15d | 2010-07-15 | 2010-08-04 | 1311121021 FS-12d, 1311121020 FS-12d, 1311122005 | 40d | 0d | MECH DES [60 h]; MECH ENG [120 h]; SCIENTIST [48 h]; SUPPLIES & MATERIALS; ELEC TECH [60 h]; MECH TECH [240 h]; SR STAFF [30 h]; COMP SCIENT [60 h]; ELEC ENG [120 h] | 42,683.37 | HOGAN J | 1 | 1 |  | JOHN H | 08-050 |  | 09-017 | 09-032 | 09-032 |  | 10-027 |  | 10-064 | 11-003 | 11-012 | 11-051 |  |  |  |  |
| 1311122015 |  | Receive and Inspect Cavities 9 Thru 14 |  | 15d | 2010-09-10 | 2010-09-30 | 1311121025 FS-15d, 1311121026 FS-15d, 1317000, 1311122010 | 37d | 0d | ELEC TECH [30 h]; SUPPLIES & MATERIALS; MECH DES [30 h]; MECH ENG [90 h]; SCIENTIST [48 h]; COMP SCIENT [30 h]; ELEC ENG [120 h]; SR STAFF [30 h]; MECH TECH [240 h] | 36,258.57 | HOGAN J | 1 | 1 |  | JOHN H | 08-050 |  | 09-017 | 09-032 | 09-032 | 10-023 | 10-027 |  | 10-064 | 11-003 | 11-012 | 11-051 |  |  |  |  |
| 1311122020 |  | Receive and Inspect Cavities 15 and 16 |  | 5d | 2010-10-01 | 2010-10-07 | 1311121030 FS-15d, 1317000, 1311121031 FS-15d, 1311122015 | 37d | 0d | MECH DES [10 h]; MECH ENG [30 h]; SCIENTIST [16 h]; SR STAFF [10 h]; SUPPLIES & MATERIALS; ELEC TECH [10 h]; MECH TECH [80 h]; COMP SCIENT [10 h]; ELEC ENG [40 h] | 12,471.55 | HOGAN J | 1 | 1 |  | JOHN H | 08-050 |  | 09-017 | 09-032 | 09-032 | 10-023 | 10-027 |  | 10-064 | 11-003 | 11-012 | 11-051 |  |  |  |  |
| 1311122022 |  | Receive and Inspect Cavities 17 Thru 20 |  | 10d | 2010-10-08 | 2010-10-21 | 1317000, 1311122020 | 107d | 0d | MECH ENG [60 h]; SCIENTIST [32 h]; SR STAFF [20 h]; SUPPLIES & MATERIALS; ELEC TECH [40 h]; MECH TECH [160 h]; ELEC ENG [80 h]; MECH DES [20 h] | 24,526.7 | HOGAN J | 1 | 1 |  | JOHN H | 08-050 |  | 09-017 | 09-032 | 09-032 | 10-023 | 10-027 |  | 10-064 |  | 11-012 | 11-051 | 12-018F |  |  |  |
| 1311122025 |  | Receive and Inspect Cavities 21 Thru 24 |  | 10d | 2010-10-22 | 2010-11-04 | 1311121036 FS-16d, 1311122022, 1311121035 FS-16d | 107d | 0d | MECH DES [20 h]; MECH TECH [160 h]; ELEC ENG [80 h]; MECH ENG [60 h]; SCIENTIST [32 h]; SUPPLIES & MATERIALS; ELEC TECH [40 h] | 22,336.5 | HOGAN J | 1 | 1 |  | JOHN H | 08-050 |  | 09-017 | 09-032 | 09-032 | 10-023 | 10-027 |  | 10-064 |  | 11-012 | 11-051 | 12-018F |  |  |  |
| 1311122027 |  | Receive and Inspect Cavities 25 and 26 |  | 5d | 2010-11-05 | 2010-11-11 | 1311122025 | 108d | 0d | ELEC ENG [40 h]; SUPPLIES & MATERIALS; ELEC TECH [10 h]; MECH TECH [80 h]; MECH DES [10 h]; SR STAFF [10 h]; MECH ENG [13 h]; SCIENTIST [16 h] | 10,680.5 | HOGAN J | 1 | 1 |  | JOHN H | 08-050 |  | 09-017 | 09-032 | 09-032 | 10-023 | 10-027 |  | 10-064 | 11-003 | 11-012 | 11-051 | 12-018F |  |  |  |
| 1311122030 |  | Receive and Inspect Cavities 27 Thru 32 |  | 15d | 2010-11-12 | 2010-12-06 | 1311121040 FS-17d, 1311122027, 1311121041 FS-17d | 108d | 2d | ELEC ENG [120 h]; SR STAFF [30 h]; SUPPLIES & MATERIALS; ELEC TECH [30 h]; MECH DES [30 h]; MECH ENG [39 h]; MECH TECH [240 h]; SCIENTIST [48 h] | 32,041.51 | HOGAN J | 1 | 1 |  | JOHN H | 08-050 |  | 09-017 | 09-032 | 09-032 | 10-023 | 10-027 |  | 10-064 | 11-003 | 11-012 | 11-051 | 12-018F |  |  |  |
| 1311122035 |  | Receive and Inspect Cavities 33 Thru 38 |  | 15d | 2011-01-18 | 2011-02-07 | 1317005, 1311121045 FS-12d, 1311121046 FS-12d, 1311122030 | 108d | 0d | ELEC ENG [120 h]; SCIENTIST [48 h]; SUPPLIES & MATERIALS; ELEC TECH [30 h]; SR STAFF [30 h]; MECH TECH [240 h]; MECH DES [15 h]; MECH ENG [39 h] | 31,341.31 | HOGAN J | 1 | 1 |  | JOHN H | 08-050 |  | 09-017 | 09-032 | 09-032 | 10-023 | 10-027 |  | 10-064 | 11-003 | 11-012 | 11-051 | 12-018F |  |  |  |
| 1311122065 |  | Receive and Inspect Cavities 39 and 40 |  | 5d | 2011-02-08 | 2011-02-14 | 1311121050 FS-16d, 1311121051 FS-16d, 1311122035 | 108d | 0d | SR STAFF [10 h]; SCIENTIST [16 h]; SUPPLIES & MATERIALS; ELEC TECH [10 h]; MECH TECH [80 h]; MECH ENG [13 h]; ELEC ENG [40 h]; MECH DES [5 h] | 10,447.1 | HOGAN J | 1 | 1 |  | JOHN H | 08-050 |  | 09-017 | 09-032 | 09-032 | 10-023 | 10-027 |  | 10-064 | 11-003 | 11-012 | 11-051 | 12-018F |  |  |  |
| 1311122067 |  | Receive and Inspect Cavities 41 Thru 44 |  | 10d | 2011-02-15 | 2011-03-01 | 1311122065 | 112d | 3d | SUPPLIES & MATERIALS; ELEC TECH [20 h]; ELEC ENG [80 h]; MECH DES [10 h]; SR STAFF [20 h]; MECH ENG [26 h]; SCIENTIST [32 h]; MECH TECH [160 h] | 20,894.2 | HOGAN J | 1 | 1 |  | JOHN H | 08-050 |  | 09-017 | 09-032 | 09-032 | 10-023 | 10-027 |  | 10-064 | 11-003 | 11-012 | 11-051 | 12-018F |  |  |  |
| 1311122070 |  | Receive and Inspect Cavities 45 Thru 48 |  | 10d | 2011-03-07 | 2011-03-18 | 1311121055 FS+4d, 1311121056 FS+4d, 1311122067 | 109d | 0d | SR STAFF [20 h]; MECH ENG [26 h]; ELEC ENG [80 h]; ELEC TECH [20 h]; MECH TECH [160 h]; MECH DES [10 h]; SUPPLIES & MATERIALS; SCIENTIST [32 h] | 20,894.2 | HOGAN J | 1 | 1 |  | JOHN H | 08-050 |  | 09-017 | 09-032 | 09-032 |  | 10-027 |  | 10-064 | 11-003 | 11-012 | 11-051 | 12-018F |  |  |  |
| 1311122072 |  | Receive and Inspect Cavities 49 and 50 |  | 5d | 2011-03-21 | 2011-03-25 | 1311122070 | 113d | 2d | SR STAFF [10 h]; ELEC ENG [40 h]; MECH ENG [13 h]; SCIENTIST [16 h]; SUPPLIES & MATERIALS; ELEC TECH [10 h]; MECH TECH [80 h]; MECH DES [5 h] | 10,447.1 | HOGAN J | 1 | 1 |  | JOHN H | 08-050 |  | 09-017 | 09-032 | 09-032 |  | 10-027 |  | 10-064 | 11-003 | 11-012 | 11-051 | 12-018F |  |  |  |
| 1311122075 |  | Receive and Inspect Cavities 51 Thru 56 |  | 15d | 2011-03-30 | 2011-04-19 | 1311121061 FS-2d, 1311122072, 1311121060 FS-2d | 111d | 0d | SR STAFF [30 h]; MECH ENG [39 h]; SCIENTIST [48 h]; SUPPLIES & MATERIALS; ELEC TECH [30 h]; ELEC ENG [120 h]; MECH TECH [240 h]; MECH DES [15 h] | 31,341.31 | HOGAN J | 1 | 1 |  | JOHN H | 08-050 |  | 09-017 | 09-032 | 09-032 |  | 10-027 |  | 10-064 | 11-003 | 11-012 | 11-051 | 12-018F |  |  |  |
| 1311122080 |  | Receive and Inspect Cavities 57 Thru 62 |  | 15d | 2011-04-27 | 2011-05-17 | 1311121066 FS-3d, 1311122075, 1311121065 FS-3d | 110d | 5d | MECH ENG [39 h]; SCIENTIST [48 h]; SUPPLIES & MATERIALS; ELEC TECH [30 h]; MECH TECH [240 h]; MECH DES [15 h]; ELEC ENG [120 h] | 28,056.01 | HOGAN J | 1 | 1 |  | JOHN H | 08-050 |  | 09-017 | 09-032 | 09-032 |  | 10-027 |  | 10-064 | 11-003 | 11-012 | 11-051 | 12-018F |  |  |  |
| 1311122085 |  | Receive and Inspect Cavities 63 and 64 |  | 5d | 2011-05-25 | 2011-06-01 | 1311121070 FS-4d, 1311122080, 1311121071 FS-4d | 105d | 0d | ELEC TECH [10 h]; MECH TECH [80 h]; MECH DES [5 h]; MECH ENG [13 h]; SCIENTIST [16 h]; SUPPLIES & MATERIALS; ELEC ENG [40 h] | 9,352 | HOGAN J | 1 | 1 |  | JOHN H | 08-050 |  | 09-017 | 09-032 | 09-032 |  | 10-027 |  | 10-064 | 11-003 | 11-012 | 11-051 | 12-018F |  |  |  |
| 1311122087 |  | Receive and Inspect Cavities 65 thru 68 |  | 10d | 2011-06-02 | 2011-06-15 | 1311122085 | 109d | 11d | MECH ENG [26 h]; ELEC TECH [20 h]; MECH TECH [160 h]; ELEC ENG [80 h]; SCIENTIST [32 h]; SUPPLIES & MATERIALS | 18,237.2 | HOGAN J | 1 | 1 |  | JOHN H | 08-050 |  | 09-017 | 09-032 | 09-032 |  | 10-027 |  | 10-064 | 11-003 | 11-012 | 11-051 | 12-018F |  |  |  |
| 1311122090 |  | Receive and Inspect Cavities 69 Thru 72 |  | 10d | 2011-08-01 | 2011-08-12 | 1311122087, 1311121075 FS-5d, 1311121076 FS-5d, 1317010 | 98d | 0d | ELEC ENG [80 h]; SCIENTIST [32 h]; MECH ENG [26 h]; ELEC TECH [20 h]; MECH TECH [160 h]; SUPPLIES & MATERIALS | 18,237.2 | HOGAN J | 1 | 1 |  | JOHN H | 08-050 |  | 09-017 | 09-032 | 09-032 |  | 10-027 |  | 10-064 | 11-003 | 11-012 | 11-051 | 12-018F |  |  |  |
| 1311122092 |  | Receive and Inspect Cavities 73 and 74 |  | 5d | 2011-08-15 | 2011-08-19 | 1311122090 | 98d | 0d | MECH ENG [13 h]; MECH TECH [80 h]; SCIENTIST [16 h]; SUPPLIES & MATERIALS; ELEC TECH [10 h]; ELEC ENG [40 h] | 9,118.6 | HOGAN J | 1 | 1 |  | JOHN H | 08-050 |  | 09-017 | 09-032 | 09-032 |  | 10-027 |  | 10-064 | 11-003 | 11-012 | 11-051 | 12-018F |  |  |  |
| 1311122095 |  | Receive and Inspect Cavities 75 Thru 80 |  | 15d | 2011-08-22 | 2011-09-12 | 1311121081 FS-6d, 1311121080 FS-6d, 1311122092 | 98d | 0d | SCIENTIST [48 h]; SUPPLIES & MATERIALS; MECH ENG [39 h]; ELEC TECH [30 h]; MECH TECH [240 h]; ELEC ENG [120 h] | 27,355.81 | HOGAN J | 1 | 1 |  | JOHN H | 08-050 |  | 09-017 | 09-032 | 09-032 |  | 10-027 |  | 10-064 | 11-003 | 11-012 | 11-051 | 12-018F |  |  |  |
| 1311122100 |  | Receive and Inspect Cavities 81 Thru 86 FY11 |  | 14d | 2011-09-13 | 2011-09-30 | 1311121091, 1311122095, 1311121085 FS-6d, 1311121086 FS-6d | 98d | 0d | SCIENTIST [44.8 h]; MECH ENG [48.53 h]; ELEC TECH [37.33 h]; MECH TECH [224 h]; SUPPLIES & MATERIALS; ELEC ENG [112 h] | 27,251.78 | HOGAN J | 1 | 1 |  | JOHN H | 08-050 |  | 09-017 | 09-032 | 09-032 |  | 10-027 |  | 10-064 | 11-003 | 11-012 | 11-051 | 12-018F | 12-001 |  |  |
| 1311122100a |  | Receive and Inspect Cavities 81 Thru 86 FY12 |  | 1d | 2011-10-03 | 2011-10-03 | 1311122100 | 98d | 0d | ELEC ENG [8 h]; SCIENTIST [3.2 h]; MECH ENG [3.47 h]; ELEC TECH [2.67 h]; MECH TECH [16 h]; SUPPLIES & MATERIALS | 2,008.97 | HOGAN J | 1 | 1 |  | JOHN H | 08-050 |  | 09-017 | 09-032 | 09-032 |  | 10-027 |  | 10-064 | 11-003 | 11-012 | 11-051 | 12-018F | 12-001 |  |  |
| 1311122105M |  | All Cavities Recieved and Inspected | milestone | 0d | 2011-10-03 | 2011-10-03 | 1311122092, 1311122070, 1311122027, 131111020B, 1311121101LOE, 1311122080, 131111012A, 1311122087, 1311122065, 1311122100a, 131111013A, 1311122005, 1311122015, 1311122030, 1311122090, 1311122020, 1311122010, 1311122022, 131111015, 131111020, 131111020A, 1311121015LOEc, 1311122025, 1311122067, 131111013, 131111012, 1311122075, 1311122035, 1311122072, 1311122085, 1311122095, 131111011LOEb | 130d | 80d |  |  | HOGAN J | 1 | 1 |  | JOHN H | 08-050 |  | 09-017 | 09-032 | 09-032 |  | 10-027 |  | 10-064 | 11-003 | 11-012 | 11-051 | 12-018F |  | 07-024 | 07-027 |

Notes:
- 1311122035: Steps: Receive and Inspect Cavities 21 thru 24; Receive and Inspect Cavities 25 thru 32; Receive and Inspect Cavities 33 thru 40; Receive and Inspect Cavities 41 thru 48; Receive and Inspect Cavities 49 thru 56
- 1311122065: Steps: Receive and Inspect Cavities 21 thru 24; Receive and Inspect Cavities 25 thru 32; Receive and Inspect Cavities 33 thru 40; Receive and Inspect Cavities 41 thru 48; Receive and Inspect Cavities 49 thru 56
- 1311122067: Steps: Receive and Inspect Cavities 21 thru 24; Receive and Inspect Cavities 25 thru 32; Receive and Inspect Cavities 33 thru 40; Receive and Inspect Cavities 41 thru 48; Receive and Inspect Cavities 49 thru 56
- 1311122070: Steps: Receive and Inspect Cavities 21 thru 24; Receive and Inspect Cavities 25 thru 32; Receive and Inspect Cavities 33 thru 40; Receive and Inspect Cavities 41 thru 48; Receive and Inspect Cavities 49 thru 56
- 1311122072: Steps: Receive and Inspect Cavities 21 thru 24; Receive and Inspect Cavities 25 thru 32; Receive and Inspect Cavities 33 thru 40; Receive and Inspect Cavities 41 thru 48; Receive and Inspect Cavities 49 thru 56
- 1311122075: Steps: Receive and Inspect Cavities 21 thru 24; Receive and Inspect Cavities 25 thru 32; Receive and Inspect Cavities 33 thru 40; Receive and Inspect Cavities 41 thru 48; Receive and Inspect Cavities 49 thru 56
- 1311122080: Steps: Receive and Inspect Cavities 21 thru 24; Receive and Inspect Cavities 25 thru 32; Receive and Inspect Cavities 33 thru 40; Receive and Inspect Cavities 41 thru 48; Receive and Inspect Cavities 49 thru 56
- 1311122085: Steps: Receive and Inspect Cavities 21 thru 24; Receive and Inspect Cavities 25 thru 32; Receive and Inspect Cavities 33 thru 40; Receive and Inspect Cavities 41 thru 48; Receive and Inspect Cavities 49 thru 56
- 1311122087: Steps: Receive and Inspect Cavities 21 thru 24; Receive and Inspect Cavities 25 thru 32; Receive and Inspect Cavities 33 thru 40; Receive and Inspect Cavities 41 thru 48; Receive and Inspect Cavities 49 thru 56
- 1311122090: Steps: Receive and Inspect Cavities 21 thru 24; Receive and Inspect Cavities 25 thru 32; Receive and Inspect Cavities 33 thru 40; Receive and Inspect Cavities 41 thru 48; Receive and Inspect Cavities 49 thru 56
- 1311122092: Steps: Receive and Inspect Cavities 21 thru 24; Receive and Inspect Cavities 25 thru 32; Receive and Inspect Cavities 33 thru 40; Receive and Inspect Cavities 41 thru 48; Receive and Inspect Cavities 49 thru 56
- 1311122095: Steps: Receive and Inspect Cavities 21 thru 24; Receive and Inspect Cavities 25 thru 32; Receive and Inspect Cavities 33 thru 40; Receive and Inspect Cavities 41 thru 48; Receive and Inspect Cavities 49 thru 56
- 1311122100: Steps: Receive and Inspect Cavities 21 thru 24; Receive and Inspect Cavities 25 thru 32; Receive and Inspect Cavities 33 thru 40; Receive and Inspect Cavities 41 thru 48; Receive and Inspect Cavities 49 thru 56
- 1311122100a: Steps: Receive and Inspect Cavities 21 thru 24; Receive and Inspect Cavities 25 thru 32; Receive and Inspect Cavities 33 thru 40; Receive and Inspect Cavities 41 thru 48; Receive and Inspect Cavities 49 thru 56

| ID | WBS | Activity | Type | Duration | Start | Finish | Predecessors | Total float | Free float | Resources | Cost | RESP - Responsibility | STRT%COMP for CM EVM | FNSH%COMP for CM EVM | CAM RESPONSIBLE | CR 13-014 | ReBaseline Actuals Adjustment | CR 08-050 | CR 10-027 | CR 10-064 | CR 11-051 | CR 12-018 | CR 07-027 | Advance Purchase Plan > 500K | CR 08-016 | 12 GEV MAJOR PROCUREMENT CATAGORY | CR 09-012 | CR 09-032 | CR 09-032 Repair | CR 10-001 | CR 11-003 | CR 11-012 | CR 12-028 | CR 09-017 | CR 07-024 |
| --- | --- | --- | --- | --- | --- | --- | --- | --- | --- | --- | --- | --- | --- | --- | --- | --- | --- | --- | --- | --- | --- | --- | --- | --- | --- | --- | --- | --- | --- | --- | --- | --- | --- | --- | --- |
|  | 3 | **1.3.1.1.1.2.3 DUMMY** |  |  |  |  |  |  |  |  |  |  |  |  |  |  |  |  |  |  |  |  |  |  |  |  |  |  |  |  |  |  |  |  |  |
|  | 3 | **1.3.1.1.1.3 WAVEGUIDES** |  |  | 2009-01-05 | 2013-08-30 |  |  |  |  |  |  |  |  |  |  |  |  |  |  |  |  |  |  |  |  |  |  |  |  |  |  |  |  |  |
| 131113000 |  | Re-Baseline Actuals Adjustment |  | 1d | 2013-08-30 | 2013-08-30 | 9-130M FS+227d | 20d |  | PROCUREMENT>$50K 69 NO ESCALATION | 179,043.2 | HOGAN J | 1 | 1 | JOHN H | 13-014 | ADJ |  |  |  |  |  |  |  |  |  |  |  |  |  |  |  |  |  |  |
|  | 1 | **1.3.1.1.1.3.1 WAVEGUIDE FABRICATION** |  |  | 2009-01-05 | 2010-10-01 |  |  |  |  |  |  |  |  |  |  |  |  |  |  |  |  |  |  |  |  |  |  |  |  |  |  |  |  |  |
| 1311131010 |  | Proc Waveguides |  | 1d | 2009-01-05 | 2009-01-05 | 9-090M FS+60d, 11115005 | 363d | 0d | MECH ENG [40 h]; MECH DES [80 h] | 6,059.6 | HOGAN J | 1 | 1 | JOHN H |  |  | 08-050 | 10-027 | 10-064 | 11-051 | 12-018F |  |  |  |  |  |  |  |  |  |  |  |  |  |
| 1311131015 |  | Waveguides Labor Initial |  | 101d | 2009-01-06 | 2009-05-29 | 1311131010 | 379d | 0d | TRAVEL; ELEC ENG [60 h]; MECH DES [80 h]; MECH ENG [100 h]; SR STAFF [40 h]; SUPPLIES & MATERIALS | 35,711.2 | HOGAN J | 1 | 1 | JOHN H |  |  | 08-050 | 10-027 | 10-064 | 11-051 | 12-018F | 07-027 | APP | 08-016 | 3111A | 09-012 | 09-032 | 09-032 |  |  |  |  |  |  |
| 1311131015LOE |  | Waveguides Labor Final FY09 |  | 86d | 2009-06-01 | 2009-09-30 | 1311131015 | 379d | 0d | SR STAFF [10.3 h]; TRAVEL; ELEC ENG [15.45 h]; MECH DES [20.6 h]; MECH ENG [25.75 h] | 6,169.19 | HOGAN J | 1 | 1 | JOHN H |  |  | 08-050 | 10-027 | 10-064 | 11-051 | 12-018F | 07-027 | APP | 08-016 | 3111A | 09-012 | 09-032 | 09-032 | 10-001B |  |  |  |  |  |
| 1311131020 |  | Vend Fab Waveguides 1 thru 10 |  | 138d | 2009-06-01 | 2009-12-15 | 9-090M FS+162d | 234d | 0d | PROCUREMENT>$50K 69 NO ESCALATION; PROCUREMENT<$50K 60 NO ESCALATION | 55,500 | HOGAN J | 1 | 1 | JOHN H |  |  | 08-050 | 10-027 | 10-064 | 11-051 |  |  |  |  |  |  | 09-032 | 09-032 | 10-001A | 11-003 |  |  |  |  |
| 1311131025 |  | Vend Fab Waveguides 11 thru 30 |  | 179d | 2009-06-01 | 2010-02-22 | 9-090M FS+162d | 213d | 0d | PROCUREMENT<$50K 60 NO ESCALATION; PROCUREMENT>$50K 69 NO ESCALATION | 111,000 | HOGAN J | 1 | 1 | JOHN H |  |  | 08-050 | 10-027 | 10-064 | 11-051 |  |  |  |  |  |  | 09-032 | 09-032 | 10-001A | 11-003 | 11-012 |  |  |  |
| 1311131030 |  | Vend Fab Waveguides 31 thru 40 |  | 229d | 2009-06-01 | 2010-05-03 | 9-090M FS+162d | 342d | 0d | PROCUREMENT<$50K 60 NO ESCALATION; PROCUREMENT>$50K 69 NO ESCALATION | 42,270 | HOGAN J | 1 | 1 | JOHN H |  |  | 08-050 | 10-027 | 10-064 | 11-051 | 12-018F |  |  |  |  |  | 09-032 | 09-032 | 10-001A | 11-003 |  | 12-028F |  |  |
| 1311131035 |  | Vend Fab Waveguides 41 thru 50 |  | 249d | 2009-06-01 | 2010-06-01 | 9-090M FS+162d | 368d | 0d | PROCUREMENT>$50K 69 NO ESCALATION; PROCUREMENT<$50K 60 NO ESCALATION | 42,270 | HOGAN J | 1 | 1 | JOHN H |  |  | 08-050 | 10-027 | 10-064 | 11-051 | 12-018F |  |  |  |  |  | 09-032 | 09-032 | 10-001A |  |  |  |  |  |
| 1311131040 |  | Vend Fab Waveguides 51 thru 60 |  | 271d | 2009-06-01 | 2010-07-01 | 9-090M FS+162d | 366d | 0d | PROCUREMENT<$50K 60 NO ESCALATION; PROCUREMENT>$50K 69 NO ESCALATION | 42,270 | HOGAN J | 1 | 1 | JOHN H |  |  | 08-050 | 10-027 | 10-064 | 11-051 | 12-018F |  |  |  |  |  | 09-032 | 09-032 | 10-001A |  |  |  |  |  |
| 1311131045 |  | Vend Fab Waveguides 61 thru 70 |  | 292d | 2009-06-01 | 2010-08-02 | 9-090M FS+162d | 365.5d | 0d | PROCUREMENT<$50K 60 NO ESCALATION; PROCUREMENT>$50K 69 NO ESCALATION | 42,270 | HOGAN J | 1 | 1 | JOHN H |  |  | 08-050 | 10-027 | 10-064 | 11-051 | 12-018F |  |  |  |  |  | 09-032 | 09-032 | 10-001A |  |  |  |  |  |
| 1311131050 |  | Vend Fab Waveguides 71 thru 80 |  | 314d | 2009-06-01 | 2010-09-01 | 9-090M FS+162d | 364d | 0d | PROCUREMENT<$50K 60 NO ESCALATION; PROCUREMENT>$50K 69 NO ESCALATION | 42,270 | HOGAN J | 1 | 1 | JOHN H |  |  | 08-050 | 10-027 | 10-064 | 11-051 | 12-018F |  |  |  |  |  | 09-032 | 09-032 | 10-001A |  |  |  |  |  |
| 1311131055 |  | Vend Fab Waveguides 81 thru 88 |  | 335d | 2009-06-01 | 2010-10-01 | 9-090M FS+162d | 363d | 0d | PROCUREMENT>$50K 69 NO ESCALATION; PROCUREMENT<$50K 60 NO ESCALATION | 33,816 | HOGAN J | 1 | 1 | JOHN H |  |  | 08-050 | 10-027 | 10-064 | 11-051 | 12-018F |  |  |  |  |  | 09-032 | 09-032 | 10-001A |  |  |  |  |  |
| 1311131015LOEb |  | Waveguides Labor Final FY10 |  | 248d | 2009-10-01 | 2010-09-30 | 1311131015LOE | 379d | 16d | TRAVEL; ELEC ENG [44.55 h]; MECH DES [59.4 h]; MECH ENG [74.25 h]; SR STAFF [29.7 h] | 18,356.67 | HOGAN J | 1 | 1 | JOHN H |  |  |  | 10-027 | 10-064 | 11-051 | 12-018F |  | APP |  | 3111A |  |  |  | 10-001B |  |  |  |  |  |
| 1311131060 |  | Exchange Rate |  | 66d | 2010-06-30 | 2010-10-01 | 1311131010 FS+370d | 363d | 0d | PROCUREMENT<$50K 60 NO ESCALATION | 50,000 | HOGAN J | 1 | 1 | JOHN H |  |  | 08-050 | 10-027 | 10-064 | 11-051 | 12-018F |  |  |  |  |  | 09-032 | 09-032 | 10-001A |  |  |  |  |  |
|  | 2 | **1.3.1.1.1.3.2 WAVEGUIDES RECEIVE AND INSPECT** |  |  | 2009-12-16 | 2010-10-22 |  |  |  |  |  |  |  |  |  |  |  |  |  |  |  |  |  |  |  |  |  |  |  |  |  |  |  |  |  |
| 1311132010 |  | Receive & Insp Waveguides 1 thru 8 |  | 15d | 2009-12-16 | 2010-01-13 | 1311131020 | 234d | 0d | MECH DES [96 h]; SR STAFF [64 h]; MECH ENG [64 h]; COMP SCIENT [32 h]; ELEC ENG [96 h]; SUPPLIES & MATERIALS; ELEC TECH [32 h]; MECH TECH [128 h] | 30,601.98 | HOGAN J | 1 | 1 | JOHN H |  |  | 08-050 | 10-027 | 10-064 | 11-051 |  |  |  |  |  |  | 09-032 | 09-032 |  | 11-003 |  |  |  |  |
| 1311132015 |  | Receive & Insp Waveguides 9 & 10 |  | 5d | 2010-01-14 | 2010-01-21 | 1311132010 | 234d | 21d | SR STAFF [16 h]; SUPPLIES & MATERIALS; MECH DES [24 h]; MECH ENG [16 h]; MECH TECH [32 h]; COMP SCIENT [8 h]; ELEC ENG [24 h]; ELEC TECH [8 h] | 7,651.18 | HOGAN J | 1 | 1 | JOHN H |  |  | 08-050 | 10-027 | 10-064 | 11-051 |  |  |  |  |  |  | 09-032 | 09-032 |  | 11-003 | 11-012 |  |  |  |
| 1311132020 |  | Receive & Insp Waveguides 11 thru 16 |  | 15d | 2010-02-23 | 2010-03-15 | 1311132015, 1311131025 | 213d | 0d | ELEC TECH [24 h]; MECH DES [24 h]; MECH ENG [48 h]; MECH TECH [96 h]; ELEC ENG [48 h]; COMP SCIENT [24 h]; SR STAFF [48 h]; SUPPLIES & MATERIALS | 19,189.34 | HOGAN J | 1 | 1 | JOHN H |  |  | 08-050 | 10-027 | 10-064 | 11-051 |  |  |  |  |  |  | 09-032 | 09-032 |  | 11-003 | 11-012 |  |  |  |
| 1311132025 |  | Receive & Insp Waveguides 17 Thru 20 |  | 10d | 2010-03-16 | 2010-03-29 | 1311132020 | 342d | 0d | MECH ENG [32 h]; ELEC TECH [16 h]; MECH TECH [64 h]; ELEC ENG [32 h]; SR STAFF [32 h]; SUPPLIES & MATERIALS; MECH DES [16 h]; COMP SCIENT [16 h] | 12,792.98 | HOGAN J | 1 | 1 | JOHN H |  |  | 08-050 | 10-027 | 10-064 | 11-051 | 12-018F |  |  |  |  |  | 09-032 | 09-032 |  | 11-003 | 11-012 | 12-028F |  |  |
| 1311132030 |  | Receive & Insp Waveguides 21 thru 24 |  | 10d | 2010-03-30 | 2010-04-12 | 1311132025 | 342d | 0d | MECH TECH [64 h]; MECH ENG [32 h]; COMP SCIENT [14.4 h]; ELEC ENG [32 h]; SUPPLIES & MATERIALS; MECH DES [16 h]; ELEC TECH [16 h] | 9,298.55 | HOGAN J | 1 | 1 | JOHN H |  |  | 08-050 | 10-027 | 10-064 | 11-051 | 12-018F |  |  |  |  |  | 09-032 | 09-032 |  | 11-003 | 11-012 | 12-028F |  |  |
| 1311132035 |  | Receive & Insp Waveguides 25 thru 30 |  | 15d | 2010-04-13 | 2010-05-03 | 1311132030 | 342d | 0d | MECH DES [24 h]; MECH ENG [48 h]; ELEC TECH [24 h]; MECH TECH [96 h]; COMP SCIENT [21.6 h]; ELEC ENG [48 h]; SUPPLIES & MATERIALS | 13,947.69 | HOGAN J | 1 | 1 | JOHN H |  |  | 08-050 | 10-027 | 10-064 | 11-051 | 12-018F |  |  |  |  |  | 09-032 | 09-032 |  | 11-003 |  | 12-028F | 09-017 |  |
| 1311132040 |  | Receive & Insp Waveguides 31 and 32 |  | 5d | 2010-05-04 | 2010-05-10 | 1311132035, 1311131030 | 342d | 0d | ELEC TECH [8 h]; MECH ENG [16 h]; MECH TECH [32 h]; MECH DES [3.2 h]; SUPPLIES & MATERIALS | 2,928.83 | HOGAN J | 1 | 1 | JOHN H |  |  | 08-050 | 10-027 | 10-064 | 11-051 | 12-018F |  |  |  |  |  | 09-032 | 09-032 |  | 11-003 |  | 12-028F | 09-017 |  |
| 1311132045 |  | Receive & Insp Waveguides 33 thru 40 |  | 15d | 2010-05-11 | 2010-06-01 | 1311132040 | 357d | 0d | MECH TECH [128 h]; SUPPLIES & MATERIALS; MECH DES [12.8 h]; MECH ENG [64 h]; ELEC TECH [32 h] | 11,712.57 | HOGAN J | 1 | 1 | JOHN H |  |  | 08-050 | 10-027 | 10-064 | 11-051 | 12-018F |  |  |  |  |  | 09-032 | 09-032 |  | 11-003 |  |  | 09-017 |  |
| 1311132050 |  | Receive & Insp Waveguides 41 thru 48 |  | 15d | 2010-06-02 | 2010-06-22 | 1311131035, 1311132045 | 368d | 0d | MECH ENG [25.6 h]; ELEC TECH [32 h]; MECH TECH [128 h]; SUPPLIES & MATERIALS; MECH DES [12.8 h] | 9,183.93 | HOGAN J | 1 | 1 | JOHN H |  |  | 08-050 | 10-027 | 10-064 | 11-051 | 12-018F |  |  |  |  |  | 09-032 | 09-032 |  |  |  |  | 09-017 |  |
| 1311132055 |  | Receive & Insp Waveguides 49 and 50 |  | 5d | 2010-06-23 | 2010-06-29 | 1311132050 | 368d | 2d | ELEC TECH [8 h]; MECH TECH [32 h]; SUPPLIES & MATERIALS; MECH DES [3.2 h]; MECH ENG [6.4 h] | 2,296.67 | HOGAN J | 1 | 1 | JOHN H |  |  | 08-050 | 10-027 | 10-064 | 11-051 | 12-018F |  |  |  |  |  | 09-032 | 09-032 |  |  |  |  | 09-017 |  |
| 1311132060 |  | Receive & Insp Waveguides 51 thru 56 |  | 13d | 2010-07-02 | 2010-07-21 | 1311131040, 1311132055 | 366d | 0d | ELEC TECH [24 h]; MECH TECH [96 h]; SUPPLIES & MATERIALS; MECH DES [9.6 h]; MECH ENG [19.2 h] | 6,887.8 | HOGAN J | 1 | 1 | JOHN H |  |  | 08-050 | 10-027 | 10-064 | 11-051 | 12-018F |  |  |  |  |  | 09-032 | 09-032 |  |  |  |  | 09-017 |  |
| 1311132065 |  | Receive & Insp Waveguides 57 thru 60 |  | 7.5d | 2010-07-22 | 2010-08-02 | 1311132060 | 366d | 0.5d | MECH ENG [12.8 h]; ELEC TECH [16 h]; MECH TECH [64 h]; SUPPLIES & MATERIALS; MECH DES [6.4 h] | 4,591.96 | HOGAN J | 1 | 1 | JOHN H |  |  | 08-050 | 10-027 | 10-064 | 11-051 | 12-018F |  |  |  |  |  | 09-032 | 09-032 |  |  |  |  | 09-017 |  |
| 1311132070 |  | Receive & Insp Waveguides 61 thru 64 |  | 8d | 2010-08-03 | 2010-08-12 | 1311131045, 1311132065 | 365.5d | 0d | MECH ENG [12.8 h]; ELEC TECH [16 h]; MECH TECH [64 h]; SUPPLIES & MATERIALS; MECH DES [6.4 h] | 4,591.96 | HOGAN J | 1 | 1 | JOHN H |  |  | 08-050 | 10-027 | 10-064 | 11-051 | 12-018F |  |  |  |  |  | 09-032 | 09-032 |  |  |  |  | 09-017 |  |
| 1311132075 |  | Receive & Insp Waveguides 65 thru 70 |  | 12.5d | 2010-08-13 | 2010-08-31 | 1311132070 | 365.5d | 1.5d | ELEC TECH [24 h]; MECH TECH [96 h]; SUPPLIES & MATERIALS; MECH DES [9.6 h]; MECH ENG [19.2 h] | 6,887.8 | HOGAN J | 1 | 1 | JOHN H |  |  | 08-050 | 10-027 | 10-064 | 11-051 | 12-018F |  |  |  |  |  | 09-032 | 09-032 |  |  |  |  | 09-017 |  |
| 1311132080 |  | Receive & Insp Waveguides 71 and 72 |  | 5d | 2010-09-02 | 2010-09-09 | 1311131050, 1311132075 | 364d | 0d | SUPPLIES & MATERIALS; MECH DES [3.2 h]; ELEC TECH [8 h]; MECH TECH [32 h]; MECH ENG [6.4 h] | 2,296.67 | HOGAN J | 1 | 1 | JOHN H |  |  | 08-050 | 10-027 | 10-064 | 11-051 | 12-018F |  |  |  |  |  | 09-032 | 09-032 |  |  |  |  | 09-017 |  |
| 1311132085 |  | Receive & Insp Waveguides 73 thru 80 |  | 15d | 2010-09-10 | 2010-09-30 | 1311132080 | 364d | 1d | MECH DES [12.8 h]; MECH ENG [25.6 h]; ELEC TECH [32 h]; MECH TECH [128 h]; SUPPLIES & MATERIALS | 9,183.93 | HOGAN J | 1 | 1 | JOHN H |  |  | 08-050 | 10-027 | 10-064 | 11-051 | 12-018F |  |  |  |  |  | 09-032 | 09-032 |  |  |  |  | 09-017 |  |
| 1311132090 |  | Receive & Insp Waveguides 81 thru 88 |  | 15d | 2010-10-04 | 2010-10-22 | 1311132085, 1311131060, 1311131055 | 363d | 0d | MECH DES [16 h]; MECH ENG [32 h]; ELEC TECH [40 h]; MECH TECH [160 h]; SUPPLIES & MATERIALS | 11,781.23 | HOGAN J | 1 | 1 | JOHN H |  |  | 08-050 | 10-027 | 10-064 | 11-051 | 12-018F |  |  |  |  |  | 09-032 | 09-032 |  |  |  |  | 09-017 |  |
| 1311132100M |  | All Waveguides Received and Inspected | milestone | 0d | 2010-10-22 | 2010-10-22 | 1311132050, 1311132065, 1311132040, 1311132035, 1311132085, 1311131015LOEb, 1311132025, 1311132070, 1311132090, 1311132010, 1311132015, 1311132060, 1311132030, 1311132020, 1311132045, 1311132055, 1311132080, 1311132075 | 363d | 313d |  |  | HOGAN J | 1 | 1 | JOHN H |  |  | 08-050 | 10-027 | 10-064 | 11-051 | 12-018F |  |  |  |  |  | 09-032 | 09-032 |  |  |  |  | 09-017 | 07-024 |

| ID | WBS | Activity | Type | Duration | Start | Finish | Predecessors | Total float | Free float | Resources | Cost | RESP - Responsibility | STRT%COMP for CM EVM | FNSH%COMP for CM EVM | CAM RESPONSIBLE | CR 08-050 | CR 09-017 | CR 10-027 | CR 10-064 | CR 11-003 | CR 11-051 | CR 12-018 | CR 07-024 | Advance Purchase Plan > 500K | CR 09-012 | CR 09-032 | CR 09-032 Repair | CR 11-012 | CR 10-001 | CR 13-014 | ReBaseline Actuals Adjustment |
| --- | --- | --- | --- | --- | --- | --- | --- | --- | --- | --- | --- | --- | --- | --- | --- | --- | --- | --- | --- | --- | --- | --- | --- | --- | --- | --- | --- | --- | --- | --- | --- |
|  | 4 | **1.3.1.1.1.4 HELIUM VESSELS** |  |  | 2009-03-02 | 2013-08-30 |  |  |  |  |  |  |  |  |  |  |  |  |  |  |  |  |  |  |  |  |  |  |  |  |  |
| 131114010 |  | Proc Helium Vessels |  | 64d | 2009-03-02 | 2009-05-29 | 1211020M FS-42d, 9-090M | 227d | 0d | MECH DES [40 h]; MECH ENG [20 h] | 3,029.8 | HOGAN J | 1 | 1 | JOHN H | 08-050 | 09-017 | 10-027 | 10-064 | 11-003 | 11-051 | 12-018F |  |  |  |  |  |  |  |  |  |
| 131114015 |  | Helium Vessels Labor Initial |  | 2d | 2009-05-29 | 2009-06-01 | 131114010 FS-1d | 266d | 0d | SUPPLIES & MATERIALS | 39.07 | HOGAN J | 1 | 1 | JOHN H | 08-050 | 09-017 | 10-027 | 10-064 | 11-003 | 11-051 | 12-018F | 07-024 | APP | 09-012 | 09-032 | 09-032 |  |  |  |  |
| 131114016 |  | Vend Fab - Helium Vessels 1 & 2 |  | 50d | 2009-06-01 | 2009-08-10 | 131114010 | 286d | 0d | PROCUREMENT>$50K 69; PROCUREMENT<$50K 60 | 4,898.16 | HOGAN J | 1 | 1 | JOHN H | 08-050 | 09-017 | 10-027 | 10-064 | 11-003 | 11-051 |  | 07-024 | APP | 09-012 | 09-032 | 09-032 | 11-012 |  |  |  |
| 131114017 |  | Vend Fab - Helium Vessels 3 Thru 8 |  | 65d | 2009-06-01 | 2009-08-31 | 131114010 | 281d | 0d | PROCUREMENT>$50K 69; PROCUREMENT<$50K 60 | 14,694.48 | HOGAN J | 1 | 1 | JOHN H | 08-050 | 09-017 | 10-027 | 10-064 | 11-003 | 11-051 |  | 07-024 | APP | 09-012 | 09-032 | 09-032 | 11-012 |  |  |  |
| 131114020 |  | Vend Fab - Helium Vessels 9 Thru 16 |  | 80d | 2009-06-01 | 2009-09-22 | 131114010 | 291d | 0d | PROCUREMENT>$50K 69; PROCUREMENT<$50K 60 | 19,592.64 | HOGAN J | 1 | 1 | JOHN H | 08-050 | 09-017 | 10-027 | 10-064 | 11-003 | 11-051 |  | 07-024 |  |  | 09-032 | 09-032 | 11-012 |  |  |  |
| 131114025 |  | Vend Fab - Helium Vessels 17 Thru 24 |  | 95d | 2009-06-01 | 2009-10-13 | 131114010 | 366d | 0d | PROCUREMENT<$50K 60 NO ESCALATION FY10; PROCUREMENT>$50K 69 NO ESCALATION FY10 | 19,592.64 | HOGAN J | 1 | 1 | JOHN H | 08-050 | 09-017 | 10-027 | 10-064 |  | 11-051 | 12-018F | 07-024 |  |  | 09-032 | 09-032 | 11-012 |  |  |  |
| 131114030 |  | Vend Fab - Helium Vessels 25 Thru 32 |  | 110d | 2009-06-01 | 2009-11-03 | 131114010 | 389d | 0d | PROCUREMENT<$50K 60 NO ESCALATION FY10; PROCUREMENT>$50K 69 NO ESCALATION FY10 | 19,592.64 | HOGAN J | 1 | 1 | JOHN H | 08-050 | 09-017 | 10-027 | 10-064 | 11-003 | 11-051 | 12-018F | 07-024 |  |  | 09-032 | 09-032 | 11-012 |  |  |  |
| 131114035 |  | Vend Fab - Helium Vessels 33 Thru 40 |  | 125d | 2009-06-01 | 2009-11-24 | 131114010 | 400d | 0d | PROCUREMENT<$50K 60 NO ESCALATION FY10; PROCUREMENT>$50K 69 NO ESCALATION FY10 | 19,592.64 | HOGAN J | 1 | 1 | JOHN H | 08-050 | 09-017 | 10-027 | 10-064 | 11-003 | 11-051 | 12-018F | 07-024 |  |  | 09-032 | 09-032 | 11-012 |  |  |  |
| 131114040 |  | Vend Fab - Helium Vessels 41 Thru 48 |  | 140d | 2009-06-01 | 2009-12-17 | 131114010 | 409d | 0d | PROCUREMENT>$50K 69 NO ESCALATION FY10; PROCUREMENT<$50K 60 NO ESCALATION FY10 | 19,592.64 | HOGAN J | 1 | 1 | JOHN H | 08-050 | 09-017 | 10-027 | 10-064 | 11-003 | 11-051 | 12-018F | 07-024 |  |  | 09-032 | 09-032 | 11-012 |  |  |  |
| 131114045 |  | Vend Fab - Helium Vessels 49 Thru 56 |  | 175d | 2009-06-01 | 2010-02-16 | 131114010 | 398d | 0d | PROCUREMENT<$50K 60 NO ESCALATION FY10; PROCUREMENT>$50K 69 NO ESCALATION FY10 | 19,592.64 | HOGAN J | 1 | 1 | JOHN H | 08-050 | 09-017 | 10-027 | 10-064 | 11-003 | 11-051 | 12-018F | 07-024 |  |  | 09-032 | 09-032 | 11-012 |  |  |  |
| 131114050 |  | Vend Fab - Helium Vessels 57 Thru 64 |  | 190d | 2009-06-01 | 2010-03-09 | 131114010 | 407d | 0d | PROCUREMENT>$50K 69 NO ESCALATION FY10; PROCUREMENT<$50K 60 NO ESCALATION FY10 | 19,592.64 | HOGAN J | 1 | 1 | JOHN H | 08-050 | 09-017 | 10-027 | 10-064 | 11-003 | 11-051 | 12-018F | 07-024 |  |  | 09-032 | 09-032 | 11-012 |  |  |  |
| 131114055 |  | Vend Fab - Helium Vessels 65 Thru 72 |  | 205d | 2009-06-01 | 2010-03-30 | 131114010 | 447d | 0d | PROCUREMENT>$50K 69 NO ESCALATION FY10; PROCUREMENT<$50K 60 NO ESCALATION FY10 | 19,592.64 | HOGAN J | 1 | 1 | JOHN H | 08-050 | 09-017 | 10-027 | 10-064 | 11-003 | 11-051 | 12-018F | 07-024 |  |  | 09-032 | 09-032 |  |  |  |  |
| 131114060 |  | Vend Fab - Helium Vessels 73 Thru 80 |  | 220d | 2009-06-01 | 2010-04-20 | 131114010 | 451d | 0d | PROCUREMENT<$50K 60 NO ESCALATION FY10; PROCUREMENT>$50K 69 NO ESCALATION FY10 | 19,592.64 | HOGAN J | 1 | 1 | JOHN H | 08-050 | 09-017 | 10-027 | 10-064 | 11-003 | 11-051 | 12-018F | 07-024 |  |  | 09-032 | 09-032 |  |  |  |  |
| 131114065 |  | Vend Fab - Helium Vessels 81 Thru 90 |  | 235d | 2009-06-01 | 2010-05-11 | 131114010 | 441d | 0d | PROCUREMENT<$50K 60 NO ESCALATION FY10; PROCUREMENT>$50K 69 NO ESCALATION FY10 | 24,490.81 | HOGAN J | 1 | 1 | JOHN H | 08-050 | 09-017 | 10-027 | 10-064 | 11-003 | 11-051 | 12-018F | 07-024 | APP | 09-012 | 09-032 | 09-032 |  | 10-001A |  |  |
| 131114015LOE |  | Helium Vessels Labor Final FY09 |  | 85d | 2009-06-02 | 2009-09-30 | 131114015 | 266d | 0d | SUPPLIES & MATERIALS; TRAVEL; MECH ENG [34.23 h]; SR STAFF [11.41 h]; MECH DES [22.82 h] | 5,561.8 | HOGAN J | 1 | 1 | JOHN H | 08-050 | 09-017 | 10-027 | 10-064 | 11-003 | 11-051 | 12-018F | 07-024 | APP | 09-012 | 09-032 | 09-032 |  | 10-001B |  |  |
| 131114070 |  | Receive & Insp Helium Vessels 1 & 2 |  | 10d | 2009-08-11 | 2009-08-24 | 131114016 | 286d | 5d | MECH TECH [12 h]; MECH DES [8 h]; SUPPLIES & MATERIALS; MECH ENG [8 h] | 1,559.52 | HOGAN J | 1 | 1 | JOHN H | 08-050 | 09-017 | 10-027 | 10-064 | 11-003 | 11-051 |  | 07-024 |  |  | 09-032 | 09-032 | 11-012 |  |  |  |
| 131114075 |  | Receive & Insp Helium Vessels 3 Thru 8 |  | 5d | 2009-09-01 | 2009-09-08 | 131114070, 131114017 | 281d | 10d | MECH DES [24 h]; SUPPLIES & MATERIALS; MECH ENG [24 h]; MECH TECH [36 h] | 4,359.25 | HOGAN J | 1 | 1 | JOHN H | 08-050 | 09-017 | 10-027 | 10-064 | 11-003 | 11-051 |  | 07-024 |  |  | 09-032 | 09-032 | 11-012 |  |  |  |
| 131114080 |  | Receive & Insp Helium Vessels 9 Thru 16 |  | 5d | 2009-09-23 | 2009-09-29 | 131114075, 131114020 | 291d | 10d | MECH DES [17.6 h]; MECH TECH [48 h]; MECH ENG [32 h]; SUPPLIES & MATERIALS | 5,181.03 | HOGAN J | 1 | 1 | JOHN H | 08-050 | 09-017 | 10-027 | 10-064 | 11-003 | 11-051 |  | 07-024 |  |  | 09-032 | 09-032 | 11-012 |  |  |  |
| 131114015LOEb |  | Helium Vessels Labor Final FY10 |  | 213d | 2009-10-01 | 2010-08-11 | 131114015LOE | 266d | 35d | MECH ENG [85.77 h]; SR STAFF [28.59 h]; MECH DES [57.18 h]; SUPPLIES & MATERIALS; TRAVEL | 14,381.43 | HOGAN J | 1 | 1 | JOHN H |  |  | 10-027 | 10-064 | 11-003 | 11-051 | 12-018F |  | APP |  |  |  |  | 10-001B |  |  |
| 131114085 |  | Receive & Insp Helium Vessels 17 thru 24 |  | 5d | 2009-10-14 | 2009-10-20 | 131114080, 131114025 | 366d | 10d | SUPPLIES & MATERIALS; MECH DES [12.8 h]; MECH TECH [48 h]; MECH ENG [20.8 h] | 4,391.79 | HOGAN J | 1 | 1 | JOHN H | 08-050 | 09-017 | 10-027 | 10-064 |  | 11-051 | 12-018F | 07-024 |  |  | 09-032 | 09-032 | 11-012 |  |  |  |
| 131114090 |  | Receive & Insp Helium Vessels 25 Thru 32 |  | 5d | 2009-11-04 | 2009-11-10 | 131114085, 131114030 | 389d | 10d | SUPPLIES & MATERIALS; MECH DES [12.8 h]; MECH TECH [48 h]; MECH ENG [21.81 h] | 4,458.3 | HOGAN J | 1 | 1 | JOHN H | 08-050 | 09-017 | 10-027 | 10-064 | 11-003 | 11-051 | 12-018F | 07-024 |  |  | 09-032 | 09-032 | 11-012 |  |  |  |
| 131114095 |  | Receive & Insp Helium Vessels 33 Thru 40 |  | 5d | 2009-11-25 | 2009-12-03 | 131114090, 131114035 | 400d | 10d | MECH TECH [48 h]; MECH DES [12.8 h]; MECH ENG [9.6 h]; SUPPLIES & MATERIALS | 3,654.27 | HOGAN J | 1 | 1 | JOHN H | 08-050 | 09-017 | 10-027 | 10-064 | 11-003 | 11-051 | 12-018F | 07-024 |  |  | 09-032 | 09-032 | 11-012 |  |  |  |
| 131114100 |  | Receive & Insp Helium Vessels 41 thru 48 |  | 5d | 2009-12-18 | 2009-12-31 | 131114040, 131114095 | 409d | 30d | MECH DES [12.8 h]; MECH ENG [9.6 h]; SUPPLIES & MATERIALS; MECH TECH [48 h] | 3,654.27 | HOGAN J | 1 | 1 | JOHN H | 08-050 | 09-017 | 10-027 | 10-064 | 11-003 | 11-051 | 12-018F | 07-024 |  |  | 09-032 | 09-032 | 11-012 |  |  |  |
| 131114105 |  | Receive & Insp Helium Vessels 49 Thru 56 |  | 5d | 2010-02-17 | 2010-02-23 | 131114045, 131114100 | 398d | 10d | MECH TECH [48 h]; MECH ENG [9.6 h]; SUPPLIES & MATERIALS; MECH DES [12.8 h] | 3,654.27 | HOGAN J | 1 | 1 | JOHN H | 08-050 | 09-017 | 10-027 | 10-064 | 11-003 | 11-051 | 12-018F | 07-024 |  |  | 09-032 | 09-032 | 11-012 |  |  |  |
| 131114110 |  | Receive & Insp Helium Vessels 57 Thru 64 |  | 5d | 2010-03-10 | 2010-03-16 | 131114105, 131114050 | 407d | 10d | MECH TECH [48 h]; MECH ENG [9.6 h]; SUPPLIES & MATERIALS; MECH DES [12.8 h] | 3,654.27 | HOGAN J | 1 | 1 | JOHN H | 08-050 | 09-017 | 10-027 | 10-064 | 11-003 | 11-051 | 12-018F | 07-024 |  |  | 09-032 | 09-032 | 11-012 |  |  |  |
| 131114115 |  | Receive & Insp Helium Vessels 65 thru 72 |  | 5d | 2010-03-31 | 2010-04-06 | 131114055, 131114110 | 447d | 10d | MECH ENG [9.6 h]; SUPPLIES & MATERIALS; MECH TECH [48 h]; MECH DES [12.8 h] | 3,654.27 | HOGAN J | 1 | 1 | JOHN H | 08-050 | 09-017 | 10-027 | 10-064 | 11-003 | 11-051 | 12-018F | 07-024 |  |  | 09-032 | 09-032 |  |  |  |  |
| 131114120 |  | Receive & Insp Helium Vessels 73 thru 80 |  | 5d | 2010-04-21 | 2010-04-27 | 131114060, 131114115 | 451d | 10d | MECH ENG [9.6 h]; SUPPLIES & MATERIALS; MECH TECH [48 h]; MECH DES [12.8 h] | 3,654.27 | HOGAN J | 1 | 1 | JOHN H | 08-050 | 09-017 | 10-027 | 10-064 | 11-003 | 11-051 | 12-018F | 07-024 |  |  | 09-032 | 09-032 |  |  |  |  |
| 131114125 |  | Receive & Insp Helium Vessels 81 Thru 90 |  | 5d | 2010-05-12 | 2010-05-18 | 131114065, 131114120 | 441d | 214d | MECH ENG [9.6 h]; SUPPLIES & MATERIALS; MECH TECH [48 h]; MECH DES [12.8 h] | 3,654.27 | HOGAN J | 1 | 1 | JOHN H | 08-050 | 09-017 | 10-027 | 10-064 | 11-003 | 11-051 | 12-018F | 07-024 |  |  | 09-032 | 09-032 |  |  |  |  |
| 131114130 |  | Vend Fab 10 CFR 851 Compliance |  | 184d | 2010-07-01 | 2011-03-31 | 131114010 FS+270d | 227d | 0d | PROCUREMENT>$50K 69 NO ESCALATION FY11 | 275,000 | HOGAN J | 1 | 1 | JOHN H | 08-050 | 09-017 | 10-027 | 10-064 | 11-003 | 11-051 | 12-018F | 07-024 | APP | 09-012 | 09-032 | 09-032 |  | 10-001A |  |  |
| 131114015LOEc |  | SOTR Oversight FY11 |  | 116d | 2010-10-01 | 2011-03-25 | 9-110M, 131114015LOEb | 231d | 4d | MECH ENG [100 h] | 6,795 | HOGAN J | 1 | 1 | JOHN H |  |  | 10-027 | 10-064 | 11-003 | 11-051 | 12-018F |  | APP |  |  |  |  | 10-001B |  |  |
| 131114130M |  | All Helium Vessels Received and Inspected | milestone | 0d | 2011-03-31 | 2011-03-31 | 131114125, 131114015LOEb, 131114085, 131114110, 131114080, 131114120, 131114070, 131114100, 131114105, 131114115, 131114075, 131114130, 131114015LOEc, 131114090, 131114095 | 227d | 129d |  |  | HOGAN J | 1 | 1 | JOHN H | 08-050 | 09-017 | 10-027 | 10-064 | 11-003 | 11-051 | 12-018F | 07-024 |  |  | 09-032 | 09-032 |  |  |  |  |
| 131114135 |  | Re-Baseline Actuals Adjustment |  | 1d | 2013-08-30 | 2013-08-30 | 9-130M FS+227d | 20d |  | PROCUREMENT>$50K 69 NO ESCALATION | 85,759.34 | HOGAN J | 1 | 1 | JOHN H |  |  |  |  |  |  |  |  |  |  |  |  |  |  | 13-014 | ADJ |

| ID | WBS | Activity | Duration | Start | Finish | Predecessors | Total float | Free float | Resources | Cost | RESP - Responsibility | STRT%COMP for CM EVM | FNSH%COMP for CM EVM | CAM RESPONSIBLE | CR 08-050 | CR 10-027 | CR 10-064 | CR 11-003 | CR 11-051 | CR 07-024 | CR 07-027 | CR 09-017 | CR 12-018 | CR 13-014 | ReBaseline Actuals Adjustment | Profile change | CR 10-001 | CR 10-031 | CR 10-065 | CR 10-066 | CR 08-052 | 12 GEV MAJOR PROCUREMENT CATAGORY | CR 09-048 | CR 12-028 | Advance Purchase Plan > 500K | CR 09-012 | CR 11-012 |
| --- | --- | --- | --- | --- | --- | --- | --- | --- | --- | --- | --- | --- | --- | --- | --- | --- | --- | --- | --- | --- | --- | --- | --- | --- | --- | --- | --- | --- | --- | --- | --- | --- | --- | --- | --- | --- | --- |
|  | 5 | **1.3.1.1.1.5 HARDWARE** |  | 2009-03-02 | 2013-08-30 |  |  |  |  |  |  |  |  |  |  |  |  |  |  |  |  |  |  |  |  |  |  |  |  |  |  |  |  |  |  |  |  |
| 131115010 |  | Proc Hardware | 45d | 2009-03-02 | 2009-05-01 | 9-090M FS+98d | 356d | 0d | MECH ENG [40 h]; MECH DES [40 h] | 4,306 | HOGAN J | 1 | 1 | JOHN H | 08-050 | 10-027 | 10-064 | 11-003 | 11-051 |  |  |  |  |  |  |  |  |  |  |  |  |  |  |  |  |  |  |
| 131115012 |  | Vend Fab - Hardware (Phase 1) | 30d | 2009-05-01 | 2009-06-12 | 131115010 FS-1d | 356d | 0d | MECH TECH [20 h]; MECH ENG [20 h]; PROCUREMENT<$50K 60; MECH DES [20 h] | 21,596.31 | HOGAN J | 1 | 1 | JOHN H | 08-050 | 10-027 | 10-064 | 11-003 | 11-051 | 07-024 | 07-027 |  |  |  |  |  |  |  |  |  |  |  |  |  |  |  |  |
| 131115013 |  | Vend Fab - Hardware (Phase 2) | 31d | 2009-06-15 | 2009-07-28 | 131115012 | 539d | 0d | PROCUREMENT<$50K 60; MECH DES [20 h]; MECH TECH [20 h]; MECH ENG [20 h] | 21,596.31 | HOGAN J | 1 | 1 | JOHN H | 08-050 | 10-027 | 10-064 | 11-003 | 11-051 | 07-024 | 07-027 | 09-017 | 12-018F |  |  |  |  |  |  |  |  |  |  |  |  |  |  |
| 131115015 |  | Receive & Insp Hardware (Phase 1) | 16d | 2009-06-29 | 2009-07-21 | 131115010, 131115012 FS+10d | 356d | 319d | MECH TECH [40 h]; MECH ENG [20 h]; MECH DES [20 h] | 3,771 | HOGAN J | 1 | 1 | JOHN H | 08-050 | 10-027 | 10-064 | 11-003 | 11-051 |  |  | 09-017 |  |  |  |  |  |  |  |  |  |  |  |  |  |  |  |
| 131115016 |  | Receive & Insp Hardware (Phase 2) | 16d | 2009-08-12 | 2009-09-02 | 131115013 FS+10d | 539d | 425d | MECH TECH [40 h]; MECH ENG [20 h]; MECH DES [20 h] | 3,771 | HOGAN J | 1 | 1 | JOHN H | 08-050 | 10-027 | 10-064 | 11-003 | 11-051 |  |  | 09-017 | 12-018F |  |  |  |  |  |  |  |  |  |  |  |  |  |  |
| 131115020 |  | Re-Baseline Actuals Adjustment | 1d | 2013-08-30 | 2013-08-30 | 9-130M FS+227d | 20d |  | PROCUREMENT>$50K 69 NO ESCALATION | 67,377.96 | HOGAN J | 1 | 1 | JOHN H |  |  |  |  |  |  |  |  |  | 13-014 | ADJ |  |  |  |  |  |  |  |  |  |  |  |  |
|  | 6 | **1.3.1.1.1.6 MISC** |  | 2009-03-16 | 2013-08-30 |  |  |  |  |  |  |  |  |  |  |  |  |  |  |  |  |  |  |  |  |  |  |  |  |  |  |  |  |  |  |  |  |
| 131116010 |  | Proc Misc | 55d | 2009-03-16 | 2009-06-01 | 121114010M FS-132d, 9-090M FS+108d | 324d | 0d | MECH TECH [40 h]; MECH DES [40 h]; MECH ENG [16 h] | 4,392.56 | HOGAN J | 1 | 1 | JOHN H | 08-050 | 10-027 | 10-064 | 11-003 | 11-051 |  |  |  |  |  |  | C |  |  |  |  |  |  |  |  |  |  |  |
| 131116012 |  | Vend Fab - Misc (Phase 1) | 51d | 2009-06-01 | 2009-08-11 | 131116010 FS-1d | 324d | 0d | PROCUREMENT<$50K 60; MECH DES [20 h]; MECH ENG [20 h]; SUPPLIES & MATERIALS; MECH TECH [20 h] | 27,452.81 | HOGAN J | 1 | 1 | JOHN H | 08-050 | 10-027 | 10-064 | 11-003 | 11-051 |  |  |  |  |  |  |  |  |  |  |  |  |  |  |  |  |  |  |
| 131116013 |  | Vend Fab - Misc (Phase 2) Labor FY09 | 35d | 2009-08-12 | 2009-09-30 | 131116012 | 487d | 0d | MECH ENG [13.73 h]; SUPPLIES & MATERIALS; MECH TECH [13.73 h]; MECH DES [13.73 h] | 2,398.79 | HOGAN J | 1 | 1 | JOHN H | 08-050 | 10-027 | 10-064 | 11-003 | 11-051 |  |  | 09-017 | 12-018F |  |  |  | 10-001B |  |  |  |  |  |  |  |  |  |  |
| 131116013c |  | Vend Fab - Misc (Phase 2) Procurement | 51d | 2009-08-12 | 2009-10-22 | 131116012 | 487d | 0d | PROCUREMENT<$50K 60 NO ESCALATION FY10 | 23,958.4 | HOGAN J | 1 | 1 | JOHN H |  | 10-027 | 10-064 | 11-003 | 11-051 |  |  |  | 12-018F |  |  |  | 10-001B |  |  |  |  |  |  |  |  |  |  |
| 131116015 |  | Receive & Insp Misc (Phase 1) | 17d | 2009-08-12 | 2009-09-03 | 131116012, 131116010 | 324d | 287d | MECH TECH [40 h]; MECH ENG [20 h]; MECH DES [20 h] | 3,771 | HOGAN J | 1 | 1 | JOHN H | 08-050 | 10-027 | 10-064 | 11-003 | 11-051 |  |  | 09-017 |  |  |  |  |  |  |  |  |  |  |  |  |  |  |  |
| 131116013b |  | Vend Fab - Misc (Phase 2) Labor FY10 | 16d | 2009-10-01 | 2009-10-22 | 131116013 | 487d | 0d | MECH ENG [6.27 h]; SUPPLIES & MATERIALS; MECH TECH [6.27 h]; MECH DES [6.27 h] | 1,130.6 | HOGAN J | 1 | 1 | JOHN H |  | 10-027 | 10-064 | 11-003 | 11-051 |  |  |  | 12-018F |  |  |  | 10-001B |  |  |  |  |  |  |  |  |  |  |
| 131116016 |  | Receive & Insp Misc (Phase 2) | 17d | 2009-10-23 | 2009-11-16 | 131116013b, 131116013c | 487d | 373d | MECH DES [20 h]; MECH ENG [20 h]; MECH TECH [40 h] | 3,891.4 | HOGAN J | 1 | 1 | JOHN H | 08-050 | 10-027 | 10-064 | 11-003 | 11-051 |  |  | 09-017 | 12-018F |  |  |  |  |  |  |  |  |  |  |  |  |  |  |
| 131116020 |  | QC Traveler FY10 | 128d | 2010-04-01 | 2010-09-30 | 9-100M FS+120d | 126d | 0d | COMP SCIENT [40 h]; MECH ENG [560 h]; MECH TECH [342.4 h] | 53,632.58 | HOGAN J | 1 | 1 | JOHN H |  | 10-027 | 10-064 |  |  |  |  |  |  |  |  |  |  | 10-031 | 10-065 | 10-066 |  |  |  |  |  |  |  |
| 131116025 |  | QC Traveler FY11 | 58d | 2010-10-01 | 2010-12-30 | 131116020 | 126d | 54d | MECH ENG [400 h]; MECH TECH [400 h]; COMP SCIENT [120 h] | 52,038.8 | HOGAN J | 1 | 1 | JOHN H |  | 10-027 | 10-064 |  |  |  |  |  |  |  |  |  |  | 10-031 | 10-065 | 10-066 |  |  |  |  |  |  |  |
| 131116030 |  | Re-Baseline Actuals Adjustment | 1d | 2013-08-30 | 2013-08-30 | 9-130M FS+227d | 20d |  | PROCUREMENT>$50K 69 NO ESCALATION | 292,678.85 | HOGAN J | 1 | 1 | JOHN H |  |  |  |  |  |  |  |  |  | 13-014 | ADJ |  |  |  |  |  |  |  |  |  |  |  |  |
|  | 2 | **1.3.1.1.2 SPACE FRAME PROCUREMENTS** |  | 2009-02-02 | 2013-08-30 |  |  |  |  |  |  |  |  |  |  |  |  |  |  |  |  |  |  |  |  |  |  |  |  |  |  |  |  |  |  |  |  |
|  | 1 | **1.3.1.1.2.1 SPACE FRAME** |  | 2009-02-02 | 2013-08-30 |  |  |  |  |  |  |  |  |  |  |  |  |  |  |  |  |  |  |  |  |  |  |  |  |  |  |  |  |  |  |  |  |
| 131121010 |  | Proc Space Frames | 128d | 2009-02-02 | 2009-08-03 | 9-090M, 1211020M5 FS-168d | 19d | 0d | MECH DES [32 h]; MECH ENG [16 h] | 2,423.84 | HOGAN J | 1 | 1 | JOHN H | 08-050 |  |  |  |  |  |  |  |  |  |  |  |  |  |  |  | 08-052 |  |  |  |  |  |  |
| 131121010ALOE |  | Vendor Fab Space Frames Labor FY09 | 24d | 2009-08-27 | 2009-09-30 | 9-090M FS+224d | 476d | 0d | SR STAFF [2.5 h]; SUPPLIES & MATERIALS; TRAVEL; MECH DES [5 h]; MECH ENG [7.5 h] | 2,602.68 | HOGAN J | 1 | 1 | JOHN H | 08-050 | 10-027 | 10-064 |  |  |  |  | 09-017 | 12-018F |  |  |  |  |  |  | 10-066 |  | 3112A | 09-048 | 12-028F |  |  |  |
| 131121011 |  | Vend Fab Space Frames 10% of Material Costs | 102d | 2009-08-27 | 2010-01-29 | 9-090M FS+224d, 131121010 FS-45d | 274d | 64d | PROCUREMENT<$50K 60 NO ESCALATION | 18,642.9 | HOGAN J | 1 | 1 | JOHN H | 08-050 | 10-027 | 10-064 | 11-003 | 11-051 |  |  | 09-017 | 12-018F |  |  |  | 10-001A |  |  |  |  | 3112A | 09-048 |  |  |  |  |
| 131121015 |  | Vend Fab Space Frames 50% OF Cost (Fab/Ship) 1st Article | 142d | 2009-08-27 | 2010-03-29 | 9-090M FS+224d, 131121010 FS-1d | 234d | 24d | PROCUREMENT<$50K 60 NO ESCALATION | 22,260 | HOGAN J | 1 | 1 | JOHN H | 08-050 | 10-027 | 10-064 | 11-003 | 11-051 |  |  | 09-017 | 12-018F |  |  |  | 10-001A |  |  |  |  | 3112A | 09-048 |  | APP |  |  |
| 131121016 |  | Vend Fab Space Frames 50% OF Cost (Fab/Ship) Upon Receipt of 1st Article | 166d | 2009-08-27 | 2010-04-30 | 9-090M FS+224d | 210d | 0d | PROCUREMENT>$50K 69 NO ESCALATION; PROCUREMENT<$50K 60 NO ESCALATION | 22,260 | HOGAN J | 1 | 1 | JOHN H | 08-050 | 10-027 | 10-064 | 11-003 | 11-051 |  |  | 09-017 | 12-018F |  |  |  | 10-001A |  |  |  |  | 3112A | 09-048 |  | APP | 09-012 |  |
| 131121016A |  | Vend Fab Space Frames Production 90% of Material | 144d | 2009-08-27 | 2010-03-31 | 9-090M FS+224d | 345d | 85d | PROCUREMENT>$50K 69 NO ESCALATION | 167,786.1 | HOGAN J | 1 | 1 | JOHN H | 08-050 | 10-027 | 10-064 | 11-003 | 11-051 |  |  | 09-017 | 12-018F |  |  |  | 10-001A |  |  |  |  | 3112A | 09-048 | 12-028F | APP | 09-012 | 11-012 |
| 131121016B |  | Vend Fab Space Frames Deliver Space Frame #2 | 208d | 2009-08-27 | 2010-06-30 | 9-090M FS+224d | 195.5d | 0d | PROCUREMENT>$50K 69 NO ESCALATION | 16,070 | HOGAN J | 1 | 1 | JOHN H | 08-050 | 10-027 | 10-064 | 11-003 | 11-051 |  |  | 09-017 |  |  |  |  | 10-001A |  |  |  |  | 3112A | 09-048 |  | APP | 09-012 | 11-012 |
| 131121016C |  | Vend Fab Space Frames Deliver Space Frame #3 | 229d | 2009-08-27 | 2010-07-30 | 9-090M FS+224d | 260d | 0d | PROCUREMENT>$50K 69 NO ESCALATION | 16,070 | HOGAN J | 1 | 1 | JOHN H | 08-050 | 10-027 | 10-064 | 11-003 | 11-051 |  |  | 09-017 | 12-018F |  |  |  | 10-001A |  |  |  |  | 3112A | 09-048 | 12-028F | APP | 09-012 | 11-012 |
| 131121016D |  | Vend Fab Space Frames Deliver Space Frame #4 | 251d | 2009-08-27 | 2010-08-31 | 9-090M FS+224d | 279d | 0d | PROCUREMENT>$50K 69 NO ESCALATION | 16,070 | HOGAN J | 1 | 1 | JOHN H | 08-050 | 10-027 | 10-064 |  | 11-051 |  |  | 09-017 | 12-018F |  |  |  | 10-001A |  |  | 10-066 |  | 3112A | 09-048 | 12-028F | APP | 09-012 | 11-012 |
| 131121016F |  | Vend Fab Space Frames Deliver Space Frame #5 | 272d | 2009-08-27 | 2010-09-30 | 9-090M FS+224d | 313d | 0d | PROCUREMENT>$50K 69 NO ESCALATION | 16,070 | HOGAN J | 1 | 1 | JOHN H | 08-050 | 10-027 | 10-064 |  | 11-051 |  |  | 09-017 | 12-018F |  |  |  | 10-001A |  |  | 10-066 |  | 3112A | 09-048 | 12-028F | APP | 09-012 | 11-012 |
| 131121016G |  | Vend Fab Space Frames Deliver Space Frame #6 | 293d | 2009-08-27 | 2010-10-29 | 9-090M FS+224d | 345d | 0d | PROCUREMENT>$50K 69 NO ESCALATION | 16,070 | HOGAN J | 1 | 1 | JOHN H | 08-050 | 10-027 | 10-064 |  | 11-051 |  |  | 09-017 | 12-018F |  |  |  | 10-001A |  |  | 10-066 |  | 3112A | 09-048 |  | APP | 09-012 | 11-012 |
| 131121016H |  | Vend Fab Space Frames Deliver Space Frame #7 | 313d | 2009-08-27 | 2010-11-30 | 9-090M FS+224d | 429d | 0d | PROCUREMENT>$50K 69 NO ESCALATION | 16,070 | HOGAN J | 1 | 1 | JOHN H | 08-050 | 10-027 | 10-064 |  |  |  |  | 09-017 | 12-018F |  |  |  | 10-001A |  |  | 10-066 |  | 3112A | 09-048 | 12-028F | APP | 09-012 |  |
| 131121016J |  | Vend Fab Space Frames Deliver Space Frame #8 | 350d | 2009-08-27 | 2011-01-31 | 9-090M FS+224d | 451d | 0d | PROCUREMENT>$50K 69 NO ESCALATION | 16,070 | HOGAN J | 1 | 1 | JOHN H | 08-050 | 10-027 | 10-064 |  |  |  |  | 09-017 | 12-018F |  |  |  | 10-001A |  |  | 10-066 |  | 3112A | 09-048 | 12-028F | APP | 09-012 |  |
| 131121016K |  | Vend Fab Space Frames Deliver Space Frame #9 | 350d | 2009-08-27 | 2011-01-31 | 9-090M FS+224d | 496.5d | 20d | PROCUREMENT>$50K 69 NO ESCALATION | 16,070 | HOGAN J | 1 | 1 | JOHN H | 08-050 | 10-027 | 10-064 |  |  |  |  | 09-017 | 12-018F |  |  |  | 10-001A |  |  | 10-066 |  | 3112A | 09-048 | 12-028F | APP | 09-012 |  |
| 131121016L |  | Vend Fab Space Frames Deliver Space Frame #10 | 369d | 2009-08-27 | 2011-02-28 | 9-090M FS+224d | 500d | 21d | PROCUREMENT>$50K 69 NO ESCALATION | 16,070 | HOGAN J | 1 | 1 | JOHN H | 08-050 | 10-027 | 10-064 |  |  |  |  | 09-017 | 12-018F |  |  |  | 10-001A |  |  | 10-066 |  | 3112A | 09-048 | 12-028F | APP | 09-012 |  |
| 131121010BLOE |  | Vendor Fab Space Frames Labor FY10 | 248d | 2009-10-01 | 2010-09-30 | 131121010ALOE, 9-090M FS+224d | 476d | 0d | SR STAFF [26.5 h]; SUPPLIES & MATERIALS; TRAVEL; MECH DES [53 h]; MECH ENG [79.6 h] | 28,680.4 | HOGAN J | 1 | 1 | JOHN H | 08-050 | 10-027 | 10-064 |  |  |  |  | 09-017 | 12-018F |  |  |  |  |  |  | 10-066 |  | 3112A | 09-048 | 12-028F |  |  |  |
| 131121020 |  | Receive & Insp Space Frame First Article (Lab Labor) | 20d | 2010-05-03 | 2010-05-28 | 131121011, 131121015, 131121010, 131121016 | 210d | 22d | MECH ENG [22.8 h]; MECH TECH [24 h]; SUPPLIES & MATERIALS; MECH DES [15.6 h] | 3,868.15 | HOGAN J | 1 | 1 | JOHN H | 08-050 | 10-027 | 10-064 | 11-003 | 11-051 |  |  | 09-017 | 12-018F |  |  |  |  |  |  |  |  |  | 09-048 |  |  |  |  |
| 131121021 |  | Receive & Insp Space Frame #2 | 20d | 2010-07-01 | 2010-07-29 | 131121010, 131121020, 131121016, 131121016B | 195.5d | 1d | MECH DES [12.48 h]; MECH ENG [18.24 h]; MECH TECH [19.2 h]; SUPPLIES & MATERIALS | 3,226.38 | HOGAN J | 1 | 1 | JOHN H | 08-050 | 10-027 | 10-064 | 11-003 | 11-051 |  |  | 09-017 |  |  |  |  |  |  |  |  |  |  | 09-048 |  |  |  | 11-012 |
| 131121040LOE |  | SOTR Oversight FY10 | 64d | 2010-07-01 | 2010-09-30 | 9-100M FS+184d | 479d | 0d | MECH ENG [60 h] | 3,951 | HOGAN J | 1 | 1 | JOHN H | 08-050 | 10-027 | 10-064 |  |  |  |  | 09-017 | 12-018F |  |  |  |  |  |  | 10-066 |  |  | 09-048 | 12-028F |  |  |  |
| 131121022 |  | Receive & Insp Space Frame #3 | 20d | 2010-08-02 | 2010-08-27 | 131121010, 131121016A, 131121021, 131121016C | 260d | 2d | MECH TECH [16 h]; SUPPLIES & MATERIALS; MECH DES [10.4 h]; MECH ENG [15.2 h] | 2,798.53 | HOGAN J | 1 | 1 | JOHN H | 08-050 | 10-027 | 10-064 | 11-003 | 11-051 |  |  | 09-017 | 12-018F |  |  |  |  |  |  |  |  |  | 09-048 | 12-028F |  |  | 11-012 |
| 131121025 |  | Receive & Insp Space Frame #4 | 20d | 2010-09-01 | 2010-09-29 | 131121016D, 131121022 | 279d | 1d | MECH TECH [14.4 h]; MECH DES [9.36 h]; SUPPLIES & MATERIALS; MECH ENG [13.68 h] | 2,584.61 | HOGAN J | 1 | 1 | JOHN H | 08-050 | 10-027 | 10-064 |  | 11-051 |  |  | 09-017 | 12-018F |  |  |  |  |  |  | 10-066 |  |  | 09-048 | 12-028F |  |  | 11-012 |
| 131121010CLOE |  | Vendor Fab Space Frames Labor FY11 | 141d | 2010-10-01 | 2011-04-29 | 9-090M FS+224d, 131121010BLOE | 476d | 335d | SUPPLIES & MATERIALS; TRAVEL; MECH DES [22 h]; MECH ENG [32.9 h]; SR STAFF [11 h] | 12,248.07 | HOGAN J | 1 | 1 | JOHN H | 08-050 | 10-027 | 10-064 |  |  |  |  | 09-017 | 12-018F |  |  |  |  |  |  | 10-066 |  | 3112A | 09-048 | 12-028F |  |  |  |
| 131121026 |  | Receive & Insp Space Frame #5 | 20d | 2010-10-01 | 2010-10-28 | 131121016F, 131121025 | 313d | 1d | MECH ENG [13.68 h]; MECH TECH [14.4 h]; MECH DES [9.36 h]; SUPPLIES & MATERIALS | 2,666.99 | HOGAN J | 1 | 1 | JOHN H | 08-050 | 10-027 | 10-064 |  | 11-051 |  |  | 09-017 | 12-018F |  |  |  |  |  |  | 10-066 |  |  | 09-048 | 12-028F |  |  | 11-012 |
| 131121045LOE |  | SOTR Oversight FY11 | 138d | 2010-10-01 | 2011-04-26 | 131121040LOE | 479d | 338d | MECH ENG [120 h] | 8,154 | HOGAN J | 1 | 1 | JOHN H | 08-050 | 10-027 | 10-064 |  |  |  |  | 09-017 | 12-018F |  |  |  |  |  |  | 10-066 |  |  | 09-048 | 12-028F |  |  |  |
| 131121027 |  | Receive & Insp Space Frame #6 | 20d | 2010-11-01 | 2010-11-30 | 131121016G, 131121026 | 345d | 0d | SUPPLIES & MATERIALS; MECH ENG [13.68 h]; MECH TECH [14.4 h]; MECH DES [9.36 h] | 2,666.99 | HOGAN J | 1 | 1 | JOHN H | 08-050 | 10-027 | 10-064 |  | 11-051 |  |  | 09-017 | 12-018F |  |  |  |  |  |  | 10-066 |  |  | 09-048 |  |  |  | 11-012 |
| 131121028 |  | Receive & Insp Space Frame #7 | 20d | 2010-12-01 | 2011-01-05 | 131121016H, 131121027 | 429d | 17d | SUPPLIES & MATERIALS; MECH ENG [13.68 h]; MECH TECH [14.4 h]; MECH DES [9.36 h] | 2,666.99 | HOGAN J | 1 | 1 | JOHN H | 08-050 | 10-027 | 10-064 |  |  |  |  | 09-017 | 12-018F |  |  |  |  |  |  | 10-066 |  |  | 09-048 | 12-028F |  |  |  |
| 131121029 |  | Receive & Insp Space Frame #8 | 20d | 2011-02-01 | 2011-03-01 | 131121016J, 131121028 | 451d | 0d | MECH ENG [13.68 h]; MECH TECH [14.4 h]; SUPPLIES & MATERIALS; MECH DES [9.36 h] | 2,666.99 | HOGAN J | 1 | 1 | JOHN H | 08-050 | 10-027 | 10-064 |  |  |  |  | 09-017 | 12-018F |  |  |  |  |  |  | 10-066 |  |  | 09-048 | 12-028F |  |  |  |
| 131121030 |  | Receive & Insp Space Frame #9 | 20d | 2011-03-02 | 2011-03-29 | 131121029, 131121016K | 476.5d | 0d | SUPPLIES & MATERIALS; MECH TECH [14.4 h]; MECH DES [9.36 h]; MECH ENG [13.68 h] | 2,666.99 | HOGAN J | 1 | 1 | JOHN H | 08-050 | 10-027 | 10-064 |  |  |  |  | 09-017 | 12-018F |  |  |  |  |  |  | 10-066 |  |  | 09-048 | 12-028F |  |  |  |
| 131121035 |  | Receive & Insp Space Frame #10 | 20d | 2011-03-30 | 2011-04-26 | 131121030, 131121016L | 479d | 338d | MECH ENG [13.68 h]; SUPPLIES & MATERIALS; MECH TECH [14.4 h]; MECH DES [9.36 h] | 2,666.99 | HOGAN J | 1 | 1 | JOHN H | 08-050 | 10-027 | 10-064 |  |  |  |  | 09-017 | 12-018F |  |  |  |  |  |  | 10-066 |  |  | 09-048 | 12-028F |  |  |  |
| 131121050 |  | Re-Baseline Actuals Adjustment | 1d | 2013-08-30 | 2013-08-30 | 9-130M FS+227d | 20d |  | PROCUREMENT>$50K 69 NO ESCALATION | 70,849.01 | HOGAN J | 1 | 1 | JOHN H |  |  |  |  |  |  |  |  |  | 13-014 | ADJ |  |  |  |  |  |  |  |  |  |  |  |  |

| ID | WBS | Activity | Duration | Start | Finish | Predecessors | Total float | Free float | Resources | Cost | RESP - Responsibility | STRT%COMP for CM EVM | FNSH%COMP for CM EVM | CAM RESPONSIBLE | CR 08-050 | CR 09-051 | CR 10-027 | CR 10-064 | CR 11-003 | CR 11-051 | CR 12-018 | CR 07-024 | CR 07-027 | Profile change | Advance Purchase Plan > 500K | CR 08-016 | 12 GEV MAJOR PROCUREMENT CATAGORY | CR 09-012 | CR 11-012 | CR 12-028 | CR 10-066 | CR 08-052 | CR 09-017 | CR 10-012 | CR 13-014 | ReBaseline Actuals Adjustment |
| --- | --- | --- | --- | --- | --- | --- | --- | --- | --- | --- | --- | --- | --- | --- | --- | --- | --- | --- | --- | --- | --- | --- | --- | --- | --- | --- | --- | --- | --- | --- | --- | --- | --- | --- | --- | --- |
|  | 2 | **1.3.1.1.2.2 TUNERS** |  | 2009-05-01 | 2013-08-30 |  |  |  |  |  |  |  |  |  |  |  |  |  |  |  |  |  |  |  |  |  |  |  |  |  |  |  |  |  |  |  |
| 131122010 |  | Proc Tuners | 86d | 2009-05-01 | 2009-09-01 | 9-090M FS+142d | 274d | 0d | MECH DES [32 h]; MECH ENG [16 h] | 2,423.84 | HOGAN J | 1 | 1 | JOHN H | 08-050 | 09-051 | 10-027 | 10-064 | 11-003 | 11-051 | 12-018F |  |  |  |  |  |  |  |  |  |  |  |  |  |  |  |
| 131122015 |  | Vend Fab - Cold Tuners Lot #1 (Phase 1) FY09 Original Labor | 21d | 2009-09-01 | 2009-09-30 | 131122010 FS-1d | 318d | 0d | TRAVEL; MECH DES [3.36 h]; MECH ENG [6.72 h]; SR STAFF [3.36 h]; SUPPLIES & MATERIALS | 2,263.31 | HOGAN J | 1 | 1 | JOHN H | 08-050 | 09-051 | 10-027 | 10-064 | 11-003 | 11-051 |  | 07-024 | 07-027 | C | APP | 08-016 | 3112B | 09-012 | 11-012 |  |  |  |  |  |  |  |
| 131122016A |  | Vend Fab - Cold Tuners - Materials | 16d | 2009-09-09 | 2009-09-30 | 131122010 FS+4d | 274d | 0d | PROCUREMENT<$50K 60 NO ESCALATION; PROCUREMENT>$50K 69 NO ESCALATION | 140,707.2 | HOGAN J | 1 | 1 | JOHN H |  | 09-051 | 10-027 | 10-064 | 11-003 | 11-051 | 12-018F |  |  | C | APP |  | 3112B |  |  |  |  |  |  |  |  |  |
| 131122016B |  | Vend Fab - Cold Tuners - First Article | 38d | 2009-09-09 | 2009-10-30 | 131122016A FS-16d | 274d | 0d | PROCUREMENT>$50K 69 NO ESCALATION | 11,556.6 | HOGAN J | 1 | 1 | JOHN H |  | 09-051 | 10-027 | 10-064 | 11-003 | 11-051 | 12-018F |  |  | C | APP |  | 3112B |  |  |  |  |  |  |  |  |  |
| 131122016C |  | Vend Fab - Cold Tuners - 2 thru 10 | 94d | 2009-09-09 | 2010-01-29 | 131122016B FS-38d | 274d | 0d | PROCUREMENT>$50K 69 NO ESCALATION | 17,865.09 | HOGAN J | 1 | 1 | JOHN H |  | 09-051 | 10-027 | 10-064 | 11-003 | 11-051 | 12-018F |  |  | C | APP |  | 3112B |  |  |  |  |  |  |  |  |  |
| 131122016D |  | Vend Fab - Cold Tuners - 11 thru 20 | 113d | 2009-09-09 | 2010-02-26 | 131122016C FS-94d | 280d | 0d | PROCUREMENT>$50K 69 NO ESCALATION | 19,850.1 | HOGAN J | 1 | 1 | JOHN H |  | 09-051 | 10-027 | 10-064 | 11-003 | 11-051 |  |  |  | C | APP |  | 3112B |  | 11-012 |  |  |  |  |  |  |  |
| 131122016F |  | Vend Fab - Cold Tuners - 21 thru 30 | 136d | 2009-09-09 | 2010-03-31 | 131122016D FS-113d | 345d | 0d | PROCUREMENT>$50K 69 NO ESCALATION | 19,850.1 | HOGAN J | 1 | 1 | JOHN H |  | 09-051 | 10-027 | 10-064 | 11-003 | 11-051 | 12-018F |  |  | C | APP |  | 3112B |  | 11-012 | 12-028F |  |  |  |  |  |  |
| 131122016G |  | Vend Fab - Cold Tuners - 31 thru 40 | 158d | 2009-09-09 | 2010-04-30 | 131122016F FS-136d | 354d | 0d | PROCUREMENT>$50K 69 NO ESCALATION | 19,850.1 | HOGAN J | 1 | 1 | JOHN H |  | 09-051 | 10-027 | 10-064 |  | 11-051 | 12-018F |  |  | C | APP |  | 3112B |  | 11-012 | 12-028F | 10-066 |  |  |  |  |  |
| 131122016H |  | Vend Fab - Cold Tuners - 41 thru 50 | 178d | 2009-09-09 | 2010-05-28 | 131122016G FS-158d | 389d | 0d | PROCUREMENT>$50K 69 NO ESCALATION | 19,850.1 | HOGAN J | 1 | 1 | JOHN H |  | 09-051 | 10-027 | 10-064 |  | 11-051 | 12-018F |  |  | C | APP |  | 3112B |  | 11-012 | 12-028F | 10-066 |  |  |  |  |  |
| 131122016J |  | Vend Fab - Cold Tuners - 51 thru 60 | 200d | 2009-09-09 | 2010-06-30 | 131122016H FS-178d | 425d | 0d | PROCUREMENT>$50K 69 NO ESCALATION | 19,850.1 | HOGAN J | 1 | 1 | JOHN H |  | 09-051 | 10-027 | 10-064 |  | 11-051 | 12-018F |  |  | C | APP |  | 3112B |  | 11-012 |  | 10-066 |  |  |  |  |  |
| 131122016K |  | Vend Fab - Cold Tuners - 61 thru 70 | 221d | 2009-09-09 | 2010-07-30 | 131122016J FS-200d | 513d | 0d | PROCUREMENT>$50K 69 NO ESCALATION | 19,850.1 | HOGAN J | 1 | 1 | JOHN H |  | 09-051 | 10-027 | 10-064 |  |  | 12-018F |  |  | C | APP |  | 3112B |  |  | 12-028F | 10-066 |  |  |  |  |  |
| 131122016L |  | Vend Fab - Cold Tuners - 71 thru 80 | 243d | 2009-09-09 | 2010-08-31 | 131122016K FS-221d | 570d | 0d | PROCUREMENT>$50K 69 NO ESCALATION | 19,850.1 | HOGAN J | 1 | 1 | JOHN H |  | 09-051 | 10-027 | 10-064 |  |  | 12-018F |  |  | C | APP |  | 3112B |  |  | 12-028F | 10-066 |  |  |  |  |  |
| 131122016N |  | Vend Fab - Cold Tuners - 81 thru 84 | 264d | 2009-09-09 | 2010-09-30 | 131122016L FS-243d | 572d | 0d | PROCUREMENT>$50K 69 NO ESCALATION | 7,940.04 | HOGAN J | 1 | 1 | JOHN H |  | 09-051 | 10-027 | 10-064 |  |  | 12-018F |  |  | C | APP |  | 3112B |  |  | 12-028F | 10-066 |  |  |  |  |  |
| 131122015A |  | Vend Fab - Cold Tuners Lot #1 (Phase 1) FY10 Original Labor | 79d | 2009-10-01 | 2010-02-01 | 131122015 | 318d | 0d | SR STAFF [12.64 h]; SUPPLIES & MATERIALS; TRAVEL; MECH DES [12.64 h]; MECH ENG [25.28 h] | 8,786.13 | HOGAN J | 1 | 1 | JOHN H |  | 09-051 | 10-027 | 10-064 | 11-003 | 11-051 |  |  |  | C | APP |  | 3112B |  | 11-012 |  |  |  |  |  |  |  |
| 131122065 |  | Vend Fab - Warm Tuners Lot # 1 | 180d | 2009-10-01 | 2010-06-24 | 9-100M | 168d | 64d | PROCUREMENT>$50K 69; PROCUREMENT<$50K 60 | 140,222.77 | HOGAN J | 1 | 1 | JOHN H | 08-050 |  | 10-027 | 10-064 | 11-003 | 11-051 | 12-018F | 07-024 | 07-027 | C | APP |  | 3112C |  |  |  |  | 08-052 | 09-017 | 10-012 |  |  |
| 131122017 |  | Receive & Insp First Article Tuner | 10d | 2009-11-02 | 2009-11-13 | 131122016B, 131122015A FS-64d, 131122015 FS-64d | 335d | 66d | MECH ENG [8 h]; MECH TECH [8 h]; SUPPLIES & MATERIALS; MECH DES [8 h] | 1,332.52 | HOGAN J | 1 | 1 | JOHN H | 08-050 | 09-051 | 10-027 | 10-064 | 11-003 | 11-051 | 12-018F |  |  |  |  |  |  |  |  |  |  |  |  |  |  |  |
| 131122020 |  | Receive & Insp Tuners Lot #1 2-10 | 15d | 2010-02-01 | 2010-02-22 | 131122016C, 131122015 FS-64d, 131122015A FS-64d | 274d | 5d | MECH TECH [32 h]; SUPPLIES & MATERIALS; MECH DES [32 h]; MECH ENG [32 h] | 5,330.08 | HOGAN J | 1 | 1 | JOHN H | 08-050 | 09-051 | 10-027 | 10-064 | 11-003 | 11-051 | 12-018F |  |  |  |  |  |  |  |  |  |  |  |  |  |  |  |
| 131122016 |  | Vend Fab - Cold Tuners Lot #2 & 3 (Phase 2) Original Labor | 120d | 2010-02-02 | 2010-07-22 | 131122015, 131122015A | 397d | 43d | TRAVEL; MECH DES [24 h]; MECH ENG [48 h]; SR STAFF [24 h]; SUPPLIES & MATERIALS | 16,682.51 | HOGAN J | 1 | 1 | JOHN H | 08-050 | 09-051 | 10-027 | 10-064 | 11-003 | 11-051 | 12-018F | 07-024 | 07-027 | C | APP | 08-016 | 3112B | 09-012 | 11-012 | 12-028F | 10-066 |  |  |  |  |  |
| 131122025 |  | Receive & Insp Tuners Lot #2 11-20 | 20d | 2010-03-01 | 2010-03-26 | 131122020 FS-1d, 131122015 FS-20d, 131122016D, 131122017 FS-1d, 131122015A FS-20d | 280d | 3d | MECH TECH [40 h]; MECH DES [8 h]; SUPPLIES & MATERIALS; MECH ENG [40 h] | 5,214.91 | HOGAN J | 1 | 1 | JOHN H | 08-050 | 09-051 | 10-027 | 10-064 | 11-003 | 11-051 |  |  |  |  |  |  |  |  | 11-012 |  |  |  |  |  |  |  |
| 131122030 |  | Receive & Insp Tuners Lot #3 21-30 | 20d | 2010-04-01 | 2010-04-28 | 131122025, 131122015A, 131122016F, 131122015 | 345d | 2d | MECH ENG [12 h]; SUPPLIES & MATERIALS; MECH TECH [40 h]; MECH DES [8 h] | 3,371.11 | HOGAN J | 1 | 1 | JOHN H | 08-050 | 09-051 | 10-027 | 10-064 | 11-003 | 11-051 | 12-018F |  |  |  |  |  |  |  | 11-012 | 12-028F |  |  |  |  |  |  |
| 131122035 |  | Receive & Insp Tuners Lot #4 31-40 | 20d | 2010-05-03 | 2010-05-28 | 131122016G, 131122016 FS-100d, 131122030 | 354d | 0d | MECH DES [8 h]; MECH ENG [12 h]; SUPPLIES & MATERIALS; MECH TECH [40 h] | 3,371.11 | HOGAN J | 1 | 1 | JOHN H | 08-050 | 09-051 | 10-027 | 10-064 |  | 11-051 | 12-018F |  |  |  |  |  |  |  | 11-012 | 12-028F | 10-066 |  |  |  |  |  |
| 131122065B |  | Vend Fab - Warm Tuners Peg Point #1 Receipt of Materials | 47d | 2010-05-25 | 2010-07-30 | 9-100M FS+158d | 103d | 0d | PROCUREMENT>$50K 69 NO ESCALATION; PROCUREMENT<$50K 60 NO ESCALATION | 100,000 | HOGAN J | 1 | 1 | JOHN H |  |  | 10-027 | 10-064 | 11-003 | 11-051 | 12-018F |  |  | C | APP |  | 3112C |  |  |  |  |  |  | 10-012 |  |  |
| 131122065C |  | Vend Fab - Warm Tuners Peg Point #2 Receipt of Balance of Materials | 69d | 2010-05-25 | 2010-08-31 | 131122065B FS-47d | 103d | 0d | PROCUREMENT>$50K 69 | 100,172.5 | HOGAN J | 1 | 1 | JOHN H | 08-050 |  | 10-027 | 10-064 | 11-003 | 11-051 | 12-018F | 07-024 | 07-027 | C | APP |  | 3112C |  |  |  |  | 08-052 | 09-017 | 10-012 |  |  |
| 131122065D |  | Vend Fab - Warm Tuners Peg Point #3 Receipt of R100 Materials | 69d | 2010-05-25 | 2010-08-31 | 131122065C FS-69d | 103d | 0d |  |  | HOGAN J | 1 | 1 | JOHN H | 08-050 |  | 10-027 | 10-064 | 11-003 | 11-051 | 12-018F | 07-024 | 07-027 | C | APP |  | 3112C |  |  |  |  | 08-052 | 09-017 | 10-012 |  |  |
| 131122065F |  | Vend Fab - Warm Tuners Peg Point #4 Receipt of First Article | 90d | 2010-05-25 | 2010-09-30 | 131122065D FS-69d | 103d | 0d | PROCUREMENT>$50K 69 | 4,446.51 | HOGAN J | 1 | 1 | JOHN H | 08-050 |  | 10-027 | 10-064 | 11-003 | 11-051 | 12-018F | 07-024 | 07-027 | C | APP |  | 3112C |  |  |  |  | 08-052 | 09-017 | 10-012 |  |  |
| 131122065G |  | Vend Fab - Warm Tuners Peg Point #5 Receipt of 1st Production Set | 111d | 2010-05-25 | 2010-10-29 | 131122065F FS-90d | 103d | 0d | PROCUREMENT>$50K 69 NO ESCALATION | 20,815 | HOGAN J | 1 | 1 | JOHN H | 08-050 |  | 10-027 | 10-064 | 11-003 | 11-051 | 12-018F | 07-024 | 07-027 | C | APP |  | 3112C |  |  |  |  | 08-052 | 09-017 | 10-012 |  |  |
| 131122065H |  | Vend Fab - Warm Tuners Peg Point #6 Receipt of 2nd Production Set | 131d | 2010-05-25 | 2010-11-30 | 131122065G FS-111d | 113d | 0d | PROCUREMENT>$50K 69 NO ESCALATION | 20,815.1 | HOGAN J | 1 | 1 | JOHN H | 08-050 |  | 10-027 | 10-064 | 11-003 | 11-051 |  | 07-024 | 07-027 | C | APP |  | 3112C |  | 11-012 |  |  | 08-052 | 09-017 | 10-012 |  |  |
| 131122065J |  | Vend Fab - Warm Tuners Peg Point #7 Receipt of 3rd Production Set | 148d | 2010-05-25 | 2010-12-30 | 131122065H FS-131d | 166d | 0d | PROCUREMENT>$50K 69 NO ESCALATION | 20,815.1 | HOGAN J | 1 | 1 | JOHN H | 08-050 |  | 10-027 | 10-064 | 11-003 | 11-051 | 12-018F | 07-024 | 07-027 | C | APP |  | 3112C |  | 11-012 | 12-028F |  | 08-052 | 09-017 | 10-012 |  |  |
| 131122065K |  | Vend Fab - Warm Tuners Peg Point #8 Receipt of 4th Production Set | 187d | 2010-05-25 | 2011-02-28 | 131122065J FS-148d | 166d | 0d | PROCUREMENT>$50K 69 NO ESCALATION | 20,815.1 | HOGAN J | 1 | 1 | JOHN H | 08-050 |  | 10-027 | 10-064 |  | 11-051 | 12-018F | 07-024 | 07-027 | C | APP |  | 3112C |  | 11-012 | 12-028F | 10-066 | 08-052 | 09-017 | 10-012 |  |  |
| 131122065L |  | Vend Fab - Warm Tuners Peg Point #9 Receipt of 5th Production Set | 210d | 2010-05-25 | 2011-03-31 | 131122065K FS-187d | 203d | 0d | PROCUREMENT>$50K 69 NO ESCALATION | 20,815.1 | HOGAN J | 1 | 1 | JOHN H | 08-050 |  | 10-027 | 10-064 |  | 11-051 | 12-018F | 07-024 | 07-027 | C | APP |  | 3112C |  |  | 12-028F | 10-066 | 08-052 | 09-017 | 10-012 |  |  |
| 131122065N |  | Vend Fab - Warm Tuners Peg Point #10 Receipt of 6th Production Set | 231d | 2010-05-25 | 2011-04-29 | 131122065L FS-210d | 255d | 0d | PROCUREMENT>$50K 69 NO ESCALATION | 20,815.1 | HOGAN J | 1 | 1 | JOHN H | 08-050 |  | 10-027 | 10-064 |  | 11-051 | 12-018F | 07-024 | 07-027 | C | APP |  | 3112C |  |  |  | 10-066 | 08-052 | 09-017 | 10-012 |  |  |
| 131122065P |  | Vend Fab - Warm Tuners Peg Point #11 Receipt of 7th Production Set | 274d | 2010-05-25 | 2011-06-30 | 131122065N FS-231d | 310d | 0d | PROCUREMENT>$50K 69 NO ESCALATION | 20,815.1 | HOGAN J | 1 | 1 | JOHN H | 08-050 |  | 10-027 | 10-064 |  | 11-051 | 12-018F | 07-024 | 07-027 | C | APP |  | 3112C |  |  | 12-028F | 10-066 | 08-052 | 09-017 | 10-012 |  |  |
| 131122065Q |  | Vend Fab - Warm Tuners Peg Point #12 Receipt of 8th Production Set | 294d | 2010-05-25 | 2011-07-29 | 131122065P FS-274d | 358d | 0d | PROCUREMENT>$50K 69 NO ESCALATION | 20,815.1 | HOGAN J | 1 | 1 | JOHN H | 08-050 |  | 10-027 | 10-064 |  | 11-051 | 12-018F | 07-024 | 07-027 | C | APP |  | 3112C |  |  | 12-028F | 10-066 | 08-052 | 09-017 | 10-012 |  |  |
| 131122065R |  | Vend Fab - Warm Tuners Peg Point #13 Receipt of R100 Production Set | 317d | 2010-05-25 | 2011-08-31 | 131122065Q FS-294d | 429d | 288d |  |  | HOGAN J | 1 | 1 | JOHN H | 08-050 |  | 10-027 | 10-064 |  | 11-051 | 12-018F | 07-024 | 07-027 | C | APP |  | 3112C |  |  | 12-028F | 10-066 | 08-052 | 09-017 | 10-012 |  |  |
| 131122040 |  | Receive & Insp Tuners Lot #5 41-50 | 20d | 2010-06-01 | 2010-06-28 | 131122016 FS-80d, 131122035, 131122016H | 389d | 2d | SUPPLIES & MATERIALS; MECH ENG [12 h]; MECH TECH [40 h]; MECH DES [8 h] | 3,371.11 | HOGAN J | 1 | 1 | JOHN H | 08-050 | 09-051 | 10-027 | 10-064 |  | 11-051 | 12-018F |  |  |  |  |  |  |  | 11-012 | 12-028F | 10-066 |  |  |  |  |  |
| 131122045 |  | Receive & Insp Tuners Lot #6 51-60 | 20d | 2010-07-01 | 2010-07-29 | 131122016 FS-60d, 131122040, 131122016J | 425d | 1d | MECH TECH [40 h]; SUPPLIES & MATERIALS; MECH DES [8 h]; MECH ENG [12 h] | 3,371.11 | HOGAN J | 1 | 1 | JOHN H | 08-050 | 09-051 | 10-027 | 10-064 |  | 11-051 | 12-018F |  |  |  |  |  |  |  | 11-012 |  | 10-066 |  |  |  |  |  |
| 131122065A |  | Vend Fab - Warm Tuners Lot # 1 Reverse Entry Per CR 10-064 | 1d | 2010-07-01 | 2010-07-01 | 9-100M FS+184d | 217d | 104d | PROCUREMENT<$50K 60; PROCUREMENT>$50K 69 | -140,222.77 | HOGAN J | 1 | 1 | JOHN H |  |  | 10-027 | 10-064 | 11-003 | 11-051 |  |  |  | C | APP |  | 3112C |  | 11-012 |  |  |  |  | 10-012 |  |  |
| 131122050 |  | Receive & Insp Tuners Lot #7 61-70 | 20d | 2010-08-02 | 2010-08-27 | 131122016K, 131122045, 131122016 FS-40d | 513d | 2d | MECH DES [8 h]; MECH ENG [12 h]; SUPPLIES & MATERIALS; MECH TECH [40 h] | 3,371.11 | HOGAN J | 1 | 1 | JOHN H | 08-050 | 09-051 | 10-027 | 10-064 |  |  | 12-018F |  |  |  |  |  |  |  |  | 12-028F | 10-066 |  |  |  |  |  |
| 131122055 |  | Receive & Insp Tuners Lot #8 71-80 | 20d | 2010-09-01 | 2010-09-29 | 131122016L, 131122050, 131122016 FS-20d | 570d | 1d | MECH DES [8 h]; MECH ENG [12 h]; SUPPLIES & MATERIALS; MECH TECH [40 h] | 3,371.11 | HOGAN J | 1 | 1 | JOHN H | 08-050 | 09-051 | 10-027 | 10-064 |  |  | 12-018F |  |  |  |  |  |  |  |  | 12-028F | 10-066 |  |  |  |  |  |
| 131122060 |  | Receive & Insp Tuners Lot #9 81-84 | 20d | 2010-10-01 | 2010-10-28 | 131122016, 131122055, 131122016N | 572d | 426d | SUPPLIES & MATERIALS; MECH TECH [40 h]; MECH DES [8 h]; MECH ENG [12 h] | 3,478.56 | HOGAN J | 1 | 1 | JOHN H | 08-050 | 09-051 | 10-027 | 10-064 |  |  | 12-018F | 07-024 | 07-027 |  |  |  |  |  |  | 12-028F | 10-066 |  | 09-017 |  |  |  |
| 131122070 |  | Recieve & Inspect Warm Tuners - First Article | 20d | 2010-10-01 | 2010-10-28 | 131122065F, 131122065 FS+4d | 104d | 1d | MECH ENG [40 h]; MECH TECH [80 h] | 6,163.6 | HOGAN J | 1 | 1 | JOHN H | 08-050 |  | 10-027 | 10-064 | 11-003 | 11-051 | 12-018F | 07-024 | 07-027 | C | APP |  |  |  |  |  |  | 08-052 | 09-017 | 10-012 |  |  |
| 131122075 |  | Recieve & Inspect Warm Tuners - 1st Production Set | 20d | 2010-11-01 | 2010-11-30 | 131122065G, 131122070 | 103d | 31d | MECH ENG [24 h]; MECH TECH [40 h] | 3,353.6 | HOGAN J | 1 | 1 | JOHN H |  |  | 10-027 | 10-064 | 11-003 | 11-051 | 12-018F |  |  | C | APP |  |  |  |  |  |  |  |  | 10-012 |  |  |
| 131122080 |  | Recieve & Inspect Warm Tuners - 2nd Production Set | 20d | 2010-12-01 | 2011-01-05 | 131122065H, 131122065A | 113d | 0d | MECH ENG [24 h]; MECH TECH [40 h] | 3,353.6 | HOGAN J | 1 | 1 | JOHN H |  |  | 10-027 | 10-064 | 11-003 | 11-051 |  |  |  | C | APP |  |  |  | 11-012 |  |  |  |  | 10-012 |  |  |
| 131122085 |  | Recieve & Inspect Warm Tuners - 3rd Production Set | 20d | 2011-01-06 | 2011-02-03 | 131122080, 131122065J | 186d | 72d | MECH ENG [24 h]; MECH TECH [40 h] | 3,353.6 | HOGAN J | 1 | 1 | JOHN H |  |  | 10-027 | 10-064 | 11-003 | 11-051 | 12-018F |  |  | C | APP |  |  |  | 11-012 | 12-028F |  |  |  | 10-012 |  |  |
| 131122090 |  | Recieve & Inspect Warm Tuners - 4th Production Set | 20d | 2011-03-01 | 2011-03-28 | 131122065B, 131122065K | 166d | 3d | MECH TECH [40 h]; MECH ENG [24 h] | 3,353.6 | HOGAN J | 1 | 1 | JOHN H |  |  | 10-027 | 10-064 |  | 11-051 | 12-018F |  |  | C | APP |  |  |  | 11-012 | 12-028F | 10-066 |  |  | 10-012 |  |  |
| 131122095 |  | Recieve & Inspect Warm Tuners - 5th Production Set | 20d | 2011-04-01 | 2011-04-28 | 131122065L, 131122090 | 203d | 168d | MECH TECH [40 h]; MECH ENG [24 h] | 3,353.6 | HOGAN J | 1 | 1 | JOHN H |  |  | 10-027 | 10-064 |  | 11-051 | 12-018F |  |  | C | APP |  |  |  | 11-012 | 12-028F | 10-066 |  |  | 10-012 |  |  |
| 131122100 |  | Recieve & Inspect Warm Tuners - 6th Production Set | 20d | 2011-05-02 | 2011-05-27 | 131122065N | 255d | 163d | MECH ENG [24 h]; MECH TECH [40 h] | 3,353.6 | HOGAN J | 1 | 1 | JOHN H |  |  | 10-027 | 10-064 |  | 11-051 | 12-018F |  |  | C | APP |  |  |  | 11-012 |  | 10-066 |  |  | 10-012 |  |  |
| 131122105 |  | Recieve & Inspect Warm Tuners - 7th Production Set | 20d | 2011-07-01 | 2011-07-29 | 131122065P | 310d | 148d | MECH ENG [24 h]; MECH TECH [40 h] | 3,353.6 | HOGAN J | 1 | 1 | JOHN H |  |  | 10-027 | 10-064 |  | 11-051 | 12-018F |  |  | C | APP |  |  |  |  | 12-028F | 10-066 |  |  | 10-012 |  |  |
| 131122110 |  | Recieve & Inspect Warm Tuners - 8th Production Set | 20d | 2011-08-01 | 2011-08-26 | 131122065Q | 358d | 217d | MECH ENG [24 h]; MECH TECH [40 h] | 3,353.6 | HOGAN J | 1 | 1 | JOHN H |  |  | 10-027 | 10-064 |  | 11-051 | 12-018F |  |  | C | APP |  |  |  |  | 12-028F | 10-066 |  |  | 10-012 |  |  |
| 131122115 |  | Re-Baseline Actuals Adjustment | 1d | 2013-08-30 | 2013-08-30 | 9-130M FS+227d | 20d |  | PROCUREMENT>$50K 69 NO ESCALATION | 251,623.84 | HOGAN J | 1 | 1 | JOHN H |  |  |  |  |  |  |  |  |  |  |  |  |  |  |  |  |  |  |  |  | 13-014 | ADJ |

Notes:
- 131122065A: Explanation: Contract Award implementation captured in CR 10-064 ETC

| ID | WBS | Activity | Duration | Start | Finish | Predecessors | Total float | Free float | Resources | Cost | RESP - Responsibility | STRT%COMP for CM EVM | FNSH%COMP for CM EVM | CAM RESPONSIBLE | CR 08-050 | CR 10-027 | CR 10-064 | CR 11-003 | CR 11-051 | CR 12-018 | CR 12-028 | Advance Purchase Plan > 500K | CR 08-052 | CR 09-017 | CR 10-001 | CR 10-066 | CR 11-012 | CR 13-014 | ReBaseline Actuals Adjustment | CR 09-012 | CR 11-001 |
| --- | --- | --- | --- | --- | --- | --- | --- | --- | --- | --- | --- | --- | --- | --- | --- | --- | --- | --- | --- | --- | --- | --- | --- | --- | --- | --- | --- | --- | --- | --- | --- |
|  | 3 | **1.3.1.1.2.3 HELIUM HEADERS** |  | 2009-04-01 | 2013-08-30 |  |  |  |  |  |  |  |  |  |  |  |  |  |  |  |  |  |  |  |  |  |  |  |  |  |  |
| 131123010 |  | Proc Helium Headers | 65d | 2009-04-01 | 2009-07-01 | 9-090M FS+120d | 311d | 0d | MECH DES [32 h]; MECH ENG [16 h] | 2,423.84 | HOGAN J | 1 | 1 | JOHN H | 08-050 | 10-027 | 10-064 | 11-003 | 11-051 | 12-018F | 12-028F |  |  |  |  |  |  |  |  |  |  |
| 131123015 |  | Vend Fab - Helium Headers Lot #1, 2 & 3 (Phase 1) | 27d | 2009-07-01 | 2009-08-07 | 131123010 FS-1d | 345d | 0d | TRAVEL; MECH DES [10 h]; MECH ENG [10 h]; PROCUREMENT>$50K 69; SR STAFF [10 h]; PROCUREMENT<$50K 60; SUPPLIES & MATERIALS | 25,850.37 | HOGAN J | 1 | 1 | JOHN H | 08-050 | 10-027 | 10-064 | 11-003 | 11-051 | 12-018F |  | APP |  |  |  |  |  |  |  |  |  |
| 131123016 |  | Vend Fab - Helium Headers Lot #1, 2 & 3 (Phase 2) FY09 Labor | 37d | 2009-08-10 | 2009-09-30 | 131123015 | 458d | 0d | SR STAFF [13.88 h]; TRAVEL; MECH DES [13.88 h]; SUPPLIES & MATERIALS; MECH ENG [13.88 h] | 6,615.18 | HOGAN J | 1 | 1 | JOHN H | 08-050 | 10-027 | 10-064 |  | 11-051 | 12-018F | 12-028F | APP | 08-052 | 09-017 | 10-001B | 10-066 | 11-012 |  |  |  |  |
| 131123016c |  | Vend Fab - Helium Headers Lot #1, 2 & 3 (Phase 2) Procurement | 80d | 2009-08-10 | 2009-12-02 | 131123015 | 458d | 377d | PROCUREMENT<$50K 60 NO ESCALATION FY10; PROCUREMENT>$50K 69 NO ESCALATION FY10 | 42,805.65 | HOGAN J | 1 | 1 | JOHN H |  | 10-027 | 10-064 |  | 11-051 | 12-018F | 12-028F | APP |  |  | 10-001B | 10-066 | 11-012 |  |  |  |  |
| 131123016b |  | Vend Fab - Helium Headers Lot #1, 2 & 3 (Phase 2) FY10 Labor | 43d | 2009-10-01 | 2009-12-02 | 131123016 | 458d | 377d | MECH DES [16.12 h]; SUPPLIES & MATERIALS; MECH ENG [16.12 h]; SR STAFF [16.12 h]; TRAVEL | 7,930.9 | HOGAN J | 1 | 1 | JOHN H |  | 10-027 | 10-064 |  | 11-051 | 12-018F | 12-028F | APP |  |  | 10-001B | 10-066 | 11-012 |  |  |  |  |
| 131123020 |  | Receive & Insp Helium Headers Lot #1 1-3 | 20d | 2009-10-05 | 2009-10-30 | 131123010, 131123015 FS+39d | 345d | 0d | SUPPLIES & MATERIALS; MECH TECH [40 h]; MECH ENG [12 h]; MECH DES [8 h] | 3,371.11 | HOGAN J | 1 | 1 | JOHN H | 08-050 | 10-027 | 10-064 | 11-003 | 11-051 | 12-018F |  |  |  |  |  |  |  |  |  |  |  |
| 131123025 |  | Receive & Insp Helium Headers Lot #2 4-7 | 20d | 2009-11-02 | 2009-12-01 | 131123020, 131123015 FS-20d | 474d | 0d | MECH DES [8 h]; MECH ENG [12 h]; SUPPLIES & MATERIALS; MECH TECH [40 h] | 3,371.11 | HOGAN J | 1 | 1 | JOHN H | 08-050 | 10-027 | 10-064 |  | 11-051 | 12-018F | 12-028F |  |  |  |  | 10-066 | 11-012 |  |  |  |  |
| 131123030 |  | Receive & Insp Helium Headers Lot #3 8-10 | 20d | 2009-12-02 | 2010-01-06 | 131123015, 131123025 | 755d | 614d | MECH DES [8 h]; MECH ENG [12 h]; SUPPLIES & MATERIALS | 1,701.51 | HOGAN J | 1 | 1 | JOHN H | 08-050 | 10-027 | 10-064 |  |  | 12-018F | 12-028F |  |  |  |  | 10-066 |  |  |  |  |  |
| 131123016d |  | Vend Fab 10 CFR 851 Compliance | 5d | 2010-07-02 | 2010-07-09 | 131123010 FS+248d | 311d | 230d | PROCUREMENT>$50K 69 | 215,000 | HOGAN J | 1 | 1 | JOHN H |  | 10-027 | 10-064 |  | 11-051 | 12-018F | 12-028F | APP |  |  | 10-001B | 10-066 | 11-012 |  |  |  |  |
| 131123035 |  | Re-Baseline Actuals Adjustment | 1d | 2013-08-30 | 2013-08-30 | 9-130M FS+227d | 20d |  | PROCUREMENT>$50K 69 NO ESCALATION | 4,148.99 | HOGAN J | 1 | 1 | JOHN H |  |  |  |  |  |  |  |  |  |  |  |  |  | 13-014 | ADJ |  |  |
|  | 3 | **1.3.1.1.3 CRYOMODULE PROCUREMENTS** |  | 2009-01-02 | 2013-08-30 |  |  |  |  |  |  |  |  |  |  |  |  |  |  |  |  |  |  |  |  |  |  |  |  |  |  |
|  | 1 | **1.3.1.1.3.1 MLI** |  | 2009-03-02 | 2013-08-30 |  |  |  |  |  |  |  |  |  |  |  |  |  |  |  |  |  |  |  |  |  |  |  |  |  |  |
| 131131010 |  | Proc MLI | 65d | 2009-03-02 | 2009-06-01 | 9-090M FS+98d | 390d | 0d | MECH ENG [20 h]; MECH DES [20 h] | 2,153 | HOGAN J | 1 | 1 | JOHN H | 08-050 | 10-027 | 10-064 | 11-003 | 11-051 | 12-018F |  |  |  |  |  |  |  |  |  |  |  |
| 131131015 |  | Vend Fab - MLI (Phase 1) | 20d | 2009-06-01 | 2009-06-26 | 131131010 FS-1d | 390d | 0d | SR STAFF [10 h]; MECH DES [10 h]; MECH ENG [10 h]; MECH TECH [10 h]; PROCUREMENT<$50K 60; PROCUREMENT>$50K 69; SUPPLIES & MATERIALS | 41,907.65 | HOGAN J | 1 | 1 | JOHN H | 08-050 | 10-027 | 10-064 | 11-003 | 11-051 | 12-018F |  |  |  |  |  |  |  |  |  |  |  |
| 131131016 |  | Vend Fab - MLI (Phase 2) | 56d | 2009-06-29 | 2009-09-16 | 131131015 | 543d | 0d | PROCUREMENT>$50K 69; SUPPLIES & MATERIALS; SR STAFF [30 h]; MECH DES [30 h]; MECH ENG [30 h]; MECH TECH [30 h]; PROCUREMENT<$50K 60 | 125,722.95 | HOGAN J | 1 | 1 | JOHN H | 08-050 | 10-027 | 10-064 |  | 11-051 | 12-018F | 12-028F |  |  | 09-017 |  | 10-066 | 11-012 |  |  |  |  |
| 131131020 |  | Receive & Insp MLI (Phase 1) | 28d | 2009-06-29 | 2009-08-06 | 131131015 | 390d | 318d | MECH ENG [5 h]; SUPPLIES & MATERIALS; MECH TECH [10 h]; MECH DES [5 h] | 1,075.84 | HOGAN J | 1 | 1 | JOHN H | 08-050 | 10-027 | 10-064 | 11-003 | 11-051 | 12-018F |  |  |  | 09-017 |  |  |  |  |  |  |  |
| 131131021 |  | Receive & Insp MLI (Phase 2) FY09 | 10d | 2009-09-17 | 2009-09-30 | 131131016 | 543d | 0d | MECH TECH [10.71 h]; MECH DES [5.36 h]; MECH ENG [5.36 h]; SUPPLIES & MATERIALS | 1,152.83 | HOGAN J | 1 | 1 | JOHN H | 08-050 | 10-027 | 10-064 |  | 11-051 | 12-018F | 12-028F |  |  | 09-017 | 10-001B | 10-066 | 11-012 |  |  |  |  |
| 131131021b |  | Receive & Insp MLI (Phase 2) FY10 | 18d | 2009-10-01 | 2009-10-26 | 131131021 | 543d | 413d | MECH ENG [9.64 h]; SUPPLIES & MATERIALS; MECH TECH [19.29 h]; MECH DES [9.64 h] | 2,140.95 | HOGAN J | 1 | 1 | JOHN H |  | 10-027 | 10-064 |  | 11-051 | 12-018F | 12-028F |  |  |  | 10-001B | 10-066 | 11-012 |  |  |  |  |
| 131131025 |  | Re-Baseline Actuals Adjustment | 1d | 2013-08-30 | 2013-08-30 | 9-130M FS+227d | 20d |  | PROCUREMENT>$50K 69 NO ESCALATION | -123,888.94 | HOGAN J | 1 | 1 | JOHN H |  |  |  |  |  |  |  |  |  |  |  |  |  | 13-014 | ADJ |  |  |
|  | 2 | **1.3.1.1.3.2 THERMAL SHIELD** |  | 2009-02-02 | 2013-08-30 |  |  |  |  |  |  |  |  |  |  |  |  |  |  |  |  |  |  |  |  |  |  |  |  |  |  |
| 131132010 |  | Proc Thermal Shield | 149d | 2009-02-02 | 2009-09-01 | 9-090M FS+79d | 243d | 0d | MECH ENG [20 h]; MECH DES [20 h] | 2,153 | HOGAN J | 1 | 1 | JOHN H | 08-050 | 10-027 | 10-064 | 11-003 | 11-051 | 12-018F |  |  |  |  |  |  |  |  |  |  |  |
| 131132015 |  | Vend Fab - Thermal Shield Lot #1 (Phase 1) Labor FY09 | 21d | 2009-09-01 | 2009-09-30 | 131132010 FS-1d | 243d | 0d | SR STAFF [2.1 h]; MECH DES [4.2 h]; MECH ENG [4.2 h]; TRAVEL; SUPPLIES & MATERIALS | 1,227.12 | HOGAN J | 1 | 1 | JOHN H | 08-050 | 10-027 | 10-064 | 11-003 | 11-051 | 12-018F |  | APP |  |  | 10-001B |  |  |  |  | 09-012 |  |
| 131132015c |  | Vend Fab - Thermal Shield Lot #1 (Phase 1) Procurement | 120d | 2009-09-01 | 2010-03-02 | 131132010 FS-1d | 243d | 0d | PROCUREMENT<$50K 60 NO ESCALATION FY10; PROCUREMENT>$50K 69 NO ESCALATION FY10 | 122,986.43 | HOGAN J | 1 | 1 | JOHN H |  | 10-027 | 10-064 | 11-003 | 11-051 | 12-018F |  | APP |  |  | 10-001B |  |  |  |  |  |  |
| 131132015b |  | Vend Fab - Thermal Shield Lot #1 (Phase 1) Labor FY10 | 99d | 2009-10-01 | 2010-03-02 | 131132015 | 243d | 0d | MECH DES [19.8 h]; SUPPLIES & MATERIALS; SR STAFF [9.9 h]; MECH ENG [19.8 h]; TRAVEL | 5,969.66 | HOGAN J | 1 | 1 | JOHN H |  | 10-027 | 10-064 | 11-003 | 11-051 | 12-018F |  | APP |  |  | 10-001B |  |  |  |  |  |  |
| 131132016 |  | Vend Fab - Thermal Shield Lot #2 & 3 (Phase 2) | 120d | 2010-03-03 | 2010-08-19 | 131132015b, 131132015c | 337d | 0d | PROCUREMENT>$50K 69; MECH ENG [56 h]; TRAVEL; MECH DES [56 h]; SUPPLIES & MATERIALS; SR STAFF [28 h]; PROCUREMENT<$50K 60 | 274,549.05 | HOGAN J | 1 | 1 | JOHN H | 08-050 | 10-027 | 10-064 |  | 11-051 | 12-018F | 12-028F | APP |  |  |  | 10-066 | 11-012 |  |  | 09-012 |  |
| 131132020 |  | Receive & Insp Thermal Shield Lot #1 1-3 | 30d | 2010-03-03 | 2010-04-13 | 131132015b, 131132015c | 243d | 30d | SUPPLIES & MATERIALS; MECH DES [40 h]; MECH TECH [40 h]; MECH ENG [40 h] | 7,211.99 | HOGAN J | 1 | 1 | JOHN H | 08-050 | 10-027 | 10-064 | 11-003 | 11-051 | 12-018F |  |  |  |  |  |  |  |  |  |  |  |
| 131132025 |  | Receive & Insp Thermal Shield Lot #2 4-7 | 30d | 2010-05-26 | 2010-07-08 | 131132020, 131132016 FS-60d | 337d | 30d | MECH ENG [20 h]; MECH TECH [40 h]; MECH DES [20 h]; SUPPLIES & MATERIALS | 4,990.19 | HOGAN J | 1 | 1 | JOHN H | 08-050 | 10-027 | 10-064 |  | 11-051 | 12-018F | 12-028F |  |  |  |  | 10-066 | 11-012 |  |  |  |  |
| 131132030 |  | Receive & Insp Thermal Shield Lot #3 8-10 FY10 | 29d | 2010-08-20 | 2010-09-30 | 131132025, 131132016 | 548d | 0d | MECH ENG [19.33 h]; SUPPLIES & MATERIALS; MECH DES [19.33 h]; MECH TECH [38.67 h] | 4,823.62 | HOGAN J | 1 | 1 | JOHN H | 08-050 | 10-027 | 10-064 |  |  | 12-018F | 12-028F |  |  |  |  | 10-066 |  |  |  |  | 11-001 |
| 131132030a |  | Receive & Insp Thermal Shield Lot #3 8-10 FY11 | 1d | 2010-10-01 | 2010-10-01 | 131132030 | 548d | 407d | MECH ENG [0.67 h]; SUPPLIES & MATERIALS; MECH DES [0.67 h]; MECH TECH [1.33 h] | 171.89 | HOGAN J | 1 | 1 | JOHN H | 08-050 | 10-027 | 10-064 |  |  | 12-018F | 12-028F |  |  |  |  | 10-066 |  |  |  |  | 11-001 |
| 131132035 |  | Re-Baseline Actuals Adjustment | 1d | 2013-08-30 | 2013-08-30 | 9-130M FS+227d | 20d |  | PROCUREMENT>$50K 69 NO ESCALATION | 33,224.83 | HOGAN J | 1 | 1 | JOHN H |  |  |  |  |  |  |  |  |  |  |  |  |  | 13-014 | ADJ |  |  |

| ID | WBS | Activity | Duration | Start | Finish | Predecessors | Total float | Free float | Resources | Cost | RESP - Responsibility | STRT%COMP for CM EVM | FNSH%COMP for CM EVM | CAM RESPONSIBLE | CR 08-050 | CR 08-058 | CR 10-027 | CR 10-064 | CR 11-003 | CR 11-012 | CR 11-051 | CR 12-018 | Advance Purchase Plan > 500K | CR 10-001 | CR 09-017 | CR 12-028 | CR 10-066 | CR 12-001 | CR 13-014 | ReBaseline Actuals Adjustment |
| --- | --- | --- | --- | --- | --- | --- | --- | --- | --- | --- | --- | --- | --- | --- | --- | --- | --- | --- | --- | --- | --- | --- | --- | --- | --- | --- | --- | --- | --- | --- |
|  | 3 | **1.3.1.1.3.3 MAGNETIC SHIELD** |  | 2009-01-02 | 2013-08-30 |  |  |  |  |  |  |  |  |  |  |  |  |  |  |  |  |  |  |  |  |  |  |  |  |  |
| 131133010 |  | Prcrmnt Prep for Magnetic Shield | 28d | 2009-01-02 | 2009-02-11 | 131133010XD | 101d | 0d | MECH DES [6.44 h]; MECH ENG [6.44 h] | 693.27 | HOGAN J | 1 | 1 | JOHN H | 08-050 | 08-058 | 10-027 | 10-064 | 11-003 | 11-012 | 11-051 | 12-018F |  |  |  |  |  |  |  |  |
| 131133015 |  | Vend Fab - Magnetic Shield Lot #1 (Phase 1) | 150d | 2009-02-11 | 2009-09-14 | 131133010 FS-1d | 101d | 0d | SUPPLIES & MATERIALS; TRAVEL; MECH DES [12 h]; SR STAFF [12 h]; PROCUREMENT>$50K 69; MECH ENG [12 h]; PROCUREMENT<$50K 60 | 91,670.28 | HOGAN J | 1 | 1 | JOHN H | 08-050 |  | 10-027 | 10-064 | 11-003 | 11-012 | 11-051 | 12-018F | APP |  |  |  |  |  |  |  |
| 131133016 |  | Vend Fab - Magnetic Shield Lot #2 & 3 (Phase 2) Labor FY09 | 12d | 2009-09-15 | 2009-09-30 | 131133015 | 242d | 0d | SR STAFF [2.8 h]; MECH ENG [2.8 h]; SUPPLIES & MATERIALS; TRAVEL; MECH DES [2.8 h] | 1,334.73 | HOGAN J | 1 | 1 | JOHN H | 08-050 |  | 10-027 | 10-064 | 11-003 | 11-012 | 11-051 | 12-018F | APP | 10-001B |  |  |  |  |  |  |
| 131133016b |  | Vend Fab - Magnetic Shield Lot #2 & 3 (Phase 2) Labor FY10 | 108d | 2009-10-01 | 2010-03-15 | 131133016 | 242d | 104d | TRAVEL; MECH DES [25.2 h]; SR STAFF [25.2 h]; MECH ENG [25.2 h]; SUPPLIES & MATERIALS | 12,396.05 | HOGAN J | 1 | 1 | JOHN H |  |  | 10-027 | 10-064 | 11-003 | 11-012 | 11-051 | 12-018F | APP | 10-001B |  |  |  |  |  |  |
| 131133020 |  | Receive & Insp Inner Magnetic Shield First Article Set | 20d | 2010-01-12 | 2010-02-09 | 131133016c FS-162d, 131133015 FS+77d, 131133010 | 282d | 210d | MECH DES [20 h]; MECH ENG [20 h]; SUPPLIES & MATERIALS; MECH TECH [40 h] | 4,440.79 | HOGAN J | 1 | 1 | JOHN H | 08-050 |  | 10-027 | 10-064 | 11-003 |  | 11-051 | 12-018F |  |  | 09-017 |  |  |  |  |  |
| 131133015a |  | Vend Fab - Magnetic Shield Lot #1 (Phase 1) Reverse Entry Per CR10-064 ETC | 1d | 2010-07-01 | 2010-07-01 | 9-100M FS+184d | 182d | 63d | TRAVEL; MECH DES [-12 h]; SR STAFF [-12 h]; PROCUREMENT>$50K 69; MECH ENG [-12 h]; PROCUREMENT<$50K 60; SUPPLIES & MATERIALS | -91,750.92 | HOGAN J | 1 | 1 | JOHN H | 08-050 |  | 10-027 | 10-064 | 11-003 | 11-012 | 11-051 |  | APP |  |  |  |  |  |  |  |
| 131133016c |  | Vend Fab - Inner Magnetic Shield- First Article Set | 43d | 2010-07-01 | 2010-08-31 | 131133015 FS+196d | 119d | 0d | PROCUREMENT<$50K 60 NO ESCALATION | 22,615 | HOGAN J | 1 | 1 | JOHN H |  |  | 10-027 | 10-064 | 11-003 | 11-012 | 11-051 |  | APP |  |  |  |  |  |  |  |
| 131133016c1 |  | Vend Fab - Inner Magnetic Shield Set #2 | 64d | 2010-07-01 | 2010-09-30 | 131133016c FS-43d | 119d | 0d | PROCUREMENT<$50K 60 NO ESCALATION | 20,258 | HOGAN J | 1 | 1 | JOHN H |  |  | 10-027 | 10-064 | 11-003 | 11-012 | 11-051 |  | APP |  |  |  |  |  |  |  |
| 131133017 |  | Vend Fab - Inner Magnetic Shield Set #3 | 105d | 2010-07-01 | 2010-11-30 | 131133016c1 FS-64d | 176d | 0d | PROCUREMENT>$50K 69 NO ESCALATION; PROCUREMENT<$50K 60 NO ESCALATION | 20,258 | HOGAN J | 1 | 1 | JOHN H |  |  | 10-027 | 10-064 | 11-003 | 11-012 | 11-051 | 12-018F | APP |  |  | 12-028F |  |  |  |  |
| 131133017A |  | Vend Fab - Inner Magnetic Shield Set #4 | 105d | 2010-07-01 | 2010-11-30 | 131133017 FS-105d | 192d | 0d | PROCUREMENT>$50K 69 NO ESCALATION | 20,258 | HOGAN J | 1 | 1 | JOHN H |  |  | 10-027 | 10-064 | 11-003 | 11-012 | 11-051 | 12-018F | APP |  |  | 12-028F | 10-066 |  |  |  |
| 131133017B |  | Vend Fab - Inner Magnetic Shield Set #5 | 122d | 2010-07-01 | 2010-12-30 | 131133017A FS-105d | 235d | 0d | PROCUREMENT>$50K 69 NO ESCALATION | 20,258 | HOGAN J | 1 | 1 | JOHN H |  |  | 10-027 | 10-064 | 11-003 | 11-012 | 11-051 | 12-018F | APP |  |  | 12-028F | 10-066 |  |  |  |
| 131133017C |  | Vend Fab - Inner Magnetic Shield Set #6 | 142d | 2010-07-01 | 2011-01-31 | 131133017B FS-122d | 278d | 0d | PROCUREMENT>$50K 69 NO ESCALATION | 20,258 | HOGAN J | 1 | 1 | JOHN H |  |  | 10-027 | 10-064 | 11-003 | 11-012 | 11-051 | 12-018F | APP |  |  |  | 10-066 |  |  |  |
| 131133017D |  | Vend Fab - Inner Magnetic Shield Set #7 | 161d | 2010-07-01 | 2011-02-28 | 131133017C FS-142d | 373d | 0d | PROCUREMENT>$50K 69 NO ESCALATION | 20,258 | HOGAN J | 1 | 1 | JOHN H |  |  | 10-027 | 10-064 |  |  |  | 12-018F | APP |  |  | 12-028F | 10-066 |  |  |  |
| 131133017F |  | Vend Fab - Inner Magnetic Shield Set #8 | 184d | 2010-07-01 | 2011-03-31 | 131133017D FS-161d | 409d | 0d | PROCUREMENT>$50K 69 NO ESCALATION | 20,258 | HOGAN J | 1 | 1 | JOHN H |  |  | 10-027 | 10-064 |  |  |  | 12-018F | APP |  |  | 12-028F | 10-066 |  |  |  |
| 131133017G |  | Vend Fab - Inner Magnetic Shield Set #9 | 205d | 2010-07-01 | 2011-04-29 | 131133017F FS-184d | 421d | 0d | PROCUREMENT>$50K 69 NO ESCALATION | 20,258 | HOGAN J | 1 | 1 | JOHN H |  |  | 10-027 | 10-064 |  |  |  | 12-018F | APP |  |  | 12-028F | 10-066 |  |  |  |
| 131133017H |  | Vend Fab - Inner Magnetic Shield Set #10 | 226d | 2010-07-01 | 2011-05-31 | 131133017G FS-205d | 435d | 0d | PROCUREMENT>$50K 69 NO ESCALATION | 20,258 | HOGAN J | 1 | 1 | JOHN H |  |  | 10-027 | 10-064 |  |  |  | 12-018F | APP |  |  | 12-028F | 10-066 |  |  |  |
| 131133018 |  | Vend Fab - Outer Magnetic Shield First Article Set | 85d | 2010-07-01 | 2010-10-29 | 131133015 FS+196d | 101d | 0d | PROCUREMENT<$50K 60 NO ESCALATION | 18,933 | HOGAN J | 1 | 1 | JOHN H |  |  | 10-027 | 10-064 | 11-003 | 11-012 | 11-051 | 12-018F | APP | 10-001B |  |  |  |  |  |  |
| 131133018A |  | Vend Fab - Outer Magnetic Shield Receipt of Materials | 122d | 2010-07-01 | 2010-12-30 | 131133018 FS-85d | 101d | 0d | PROCUREMENT<$50K 60 NO ESCALATION; PROCUREMENT>$50K 69 NO ESCALATION | 62,881.43 | HOGAN J | 1 | 1 | JOHN H |  |  | 10-027 | 10-064 | 11-003 | 11-012 | 11-051 | 12-018F | APP | 10-001B |  |  |  |  |  |  |
| 131133018B |  | Vend Fab - Outer Magnetic Shield Set #2 | 122d | 2010-07-01 | 2010-12-30 | 131133018A FS-122d | 101d | 0d | PROCUREMENT>$50K 69 NO ESCALATION | 10,517.13 | HOGAN J | 1 | 1 | JOHN H |  |  | 10-027 | 10-064 | 11-003 | 11-012 | 11-051 | 12-018F | APP | 10-001B |  |  |  |  |  |  |
| 131133018C |  | Vend Fab - Outer Magnetic Shield Set #3 | 161d | 2010-07-01 | 2011-02-28 | 131133018B FS-122d | 143d | 0d | PROCUREMENT>$50K 69 NO ESCALATION | 10,517.13 | HOGAN J | 1 | 1 | JOHN H |  |  | 10-027 | 10-064 | 11-003 | 11-012 | 11-051 | 12-018F | APP | 10-001B |  | 12-028F |  |  |  |  |
| 131133018D |  | Vend Fab - Outer Magnetic Shield Set #4 | 184d | 2010-07-01 | 2011-03-31 | 131133018C FS-161d | 143d | 0d | PROCUREMENT>$50K 69 NO ESCALATION | 10,517.13 | HOGAN J | 1 | 1 | JOHN H |  |  | 10-027 | 10-064 |  | 11-012 | 11-051 | 12-018F | APP | 10-001B |  | 12-028F | 10-066 |  |  |  |
| 131133018F |  | Vend Fab - Outer Magnetic Shield Set #5 | 205d | 2010-07-01 | 2011-04-29 | 131133018D FS-184d | 182d | 0d | PROCUREMENT>$50K 69 NO ESCALATION | 10,517.13 | HOGAN J | 1 | 1 | JOHN H |  |  | 10-027 | 10-064 |  | 11-012 | 11-051 | 12-018F | APP | 10-001B |  | 12-028F | 10-066 |  |  |  |
| 131133018G |  | Vend Fab - Outer Magnetic Shield Set #6 | 226d | 2010-07-01 | 2011-05-31 | 131133018F FS-205d | 234d | 0d | PROCUREMENT>$50K 69 NO ESCALATION | 10,517.13 | HOGAN J | 1 | 1 | JOHN H |  |  | 10-027 | 10-064 |  | 11-012 | 11-051 | 12-018F | APP | 10-001B |  |  | 10-066 |  |  |  |
| 131133018H |  | Vend Fab - Outer Magnetic Shield Set #7 | 248d | 2010-07-01 | 2011-06-30 | 131133018G FS-226d | 310d | 0d | PROCUREMENT>$50K 69 NO ESCALATION | 10,517.13 | HOGAN J | 1 | 1 | JOHN H |  |  | 10-027 | 10-064 |  |  | 11-051 | 12-018F | APP | 10-001B |  | 12-028F | 10-066 |  |  |  |
| 131133018J |  | Vend Fab - Outer Magnetic Shield Set #8 | 268d | 2010-07-01 | 2011-07-29 | 131133018H FS-248d | 358d | 0d | PROCUREMENT>$50K 69 NO ESCALATION | 10,517.13 | HOGAN J | 1 | 1 | JOHN H |  |  | 10-027 | 10-064 |  |  | 11-051 | 12-018F | APP | 10-001B |  | 12-028F | 10-066 |  |  |  |
| 131133018K |  | Vend Fab - Outer Magnetic Shield Set #9 | 291d | 2010-07-01 | 2011-08-31 | 131133018J FS-268d | 379d | 0d | PROCUREMENT>$50K 69 NO ESCALATION | 10,517.13 | HOGAN J | 1 | 1 | JOHN H |  |  | 10-027 | 10-064 |  |  | 11-051 | 12-018F | APP | 10-001B |  | 12-028F | 10-066 |  |  |  |
| 131133018L |  | Vend Fab - Outer Magnetic Shield Set #10 | 308d | 2010-07-01 | 2011-09-26 | 131133018K FS-291d | 392d | 0d | PROCUREMENT>$50K 69 NO ESCALATION | 10,517.13 | HOGAN J | 1 | 1 | JOHN H |  |  | 10-027 | 10-064 |  |  | 11-051 | 12-018F | APP | 10-001B |  | 12-028F | 10-066 |  |  |  |
| 131133120LOE |  | SOTR Oversight FY10 | 64d | 2010-07-01 | 2010-09-30 | 9-100M FS+184d | 392d | 0d | MECH ENG [52 h] | 3,424.2 | HOGAN J | 1 | 1 | JOHN H | 08-050 |  | 10-027 | 10-064 |  |  | 11-051 | 12-018F |  |  | 09-017 | 12-028F | 10-066 |  |  |  |
| 131133025 |  | Receive & Insp Inner Magnetic Shield Set #2 | 20d | 2010-10-01 | 2010-10-28 | 131133016c1, 131133015a, 131133016b FS+17d | 119d | 82d | MECH ENG [8 h]; MECH TECH [40 h]; MECH DES [8 h] | 2,639.84 | HOGAN J | 1 | 1 | JOHN H | 08-050 |  | 10-027 | 10-064 | 11-003 | 11-012 | 11-051 |  |  |  | 09-017 |  |  |  |  |  |
| 131133125LOE |  | SOTR Oversight FY11 | 248d | 2010-10-01 | 2011-09-30 | 131133120LOE | 392d | 0d | MECH ENG [200 h] | 13,590 | HOGAN J | 1 | 1 | JOHN H | 08-050 |  | 10-027 | 10-064 |  |  | 11-051 | 12-018F |  |  | 09-017 | 12-028F | 10-066 |  |  |  |
| 131133070 |  | Receive & Insp Outer Magnetic Shield First Article Set | 20d | 2010-11-01 | 2010-11-30 | 131133018 | 103d | 31d | MECH TECH [40 h]; MECH DES [20 h]; MECH ENG [20 h]; SUPPLIES & MATERIALS | 4,582.32 | HOGAN J | 1 | 1 | JOHN H | 08-050 |  | 10-027 | 10-064 | 11-003 |  | 11-051 | 12-018F |  |  | 09-017 |  |  |  |  |  |
| 131133030 |  | Receive & Insp Inner Magnetic Shield Set #3 | 20d | 2010-12-01 | 2011-01-05 | 131133017, 131133016b FS+77d | 176d | 62d | MECH TECH [40 h]; MECH ENG [8 h]; MECH DES [8 h] | 2,639.84 | HOGAN J | 1 | 1 | JOHN H | 08-050 |  | 10-027 | 10-064 | 11-003 | 11-012 | 11-051 | 12-018F |  |  | 09-017 | 12-028F |  |  |  |  |
| 131133035 |  | Receive & Insp Inner Magnetic Shield Set #4 | 20d | 2010-12-01 | 2011-01-05 | 131133017A | 192d | 111d | MECH DES [8 h]; MECH ENG [8 h]; MECH TECH [40 h] | 2,639.84 | HOGAN J | 1 | 1 | JOHN H | 08-050 |  | 10-027 | 10-064 |  | 11-012 | 11-051 | 12-018F |  |  | 09-017 | 12-028F | 10-066 |  |  |  |
| 131133075 |  | Receive & Insp Outer Magnetic Shield Set #2 | 20d | 2010-12-17 | 2011-01-24 | 131133018B FS-5d | 101d | 64d | MECH DES [8 h]; MECH ENG [8 h]; MECH TECH [40 h] | 2,639.84 | HOGAN J | 1 | 1 | JOHN H | 08-050 |  | 10-027 | 10-064 | 11-003 | 11-012 | 11-051 |  |  |  | 09-017 |  |  |  |  |  |
| 131133040 |  | Receive & Insp Inner Magnetic Shield Set #5 | 20d | 2010-12-31 | 2011-01-31 | 131133017B | 235d | 105d | MECH ENG [8 h]; MECH TECH [40 h]; MECH DES [8 h] | 2,639.84 | HOGAN J | 1 | 1 | JOHN H | 08-050 |  | 10-027 | 10-064 |  | 11-012 | 11-051 | 12-018F |  |  | 09-017 | 12-028F | 10-066 |  |  |  |
| 131133045 |  | Receive & Insp Inner Magnetic Shield Set #6 | 20d | 2011-02-01 | 2011-03-01 | 131133017C | 278d | 186d | MECH TECH [40 h]; MECH DES [8 h]; MECH ENG [8 h] | 2,639.84 | HOGAN J | 1 | 1 | JOHN H | 08-050 |  | 10-027 | 10-064 |  | 11-012 | 11-051 | 12-018F |  |  | 09-017 |  | 10-066 |  |  |  |
| 131133050 |  | Receive & Insp Inner Magnetic Shield Set #7 | 20d | 2011-03-01 | 2011-03-28 | 131133017D | 373d | 211d | MECH TECH [40 h]; MECH DES [8 h]; MECH ENG [8 h] | 2,639.84 | HOGAN J | 1 | 1 | JOHN H | 08-050 |  | 10-027 | 10-064 |  |  |  | 12-018F |  |  | 09-017 | 12-028F | 10-066 |  |  |  |
| 131133080 |  | Receive & Insp Outer Magnetic Shield Set #3 | 20d | 2011-03-01 | 2011-03-28 | 131133018C | 150d | 36d | MECH ENG [8 h]; MECH TECH [40 h]; MECH DES [8 h] | 2,639.84 | HOGAN J | 1 | 1 | JOHN H | 08-050 |  | 10-027 | 10-064 | 11-003 | 11-012 | 11-051 | 12-018F |  |  | 09-017 | 12-028F |  |  |  |  |
| 131133055 |  | Receive & Insp Inner Magnetic Shield Set #8 | 20d | 2011-04-01 | 2011-04-28 | 131133017F | 409d | 268d | MECH TECH [40 h]; MECH DES [8 h]; MECH ENG [8 h] | 2,639.84 | HOGAN J | 1 | 1 | JOHN H | 08-050 |  | 10-027 | 10-064 |  |  |  | 12-018F |  |  | 09-017 | 12-028F | 10-066 |  |  |  |
| 131133085 |  | Receive & Insp Outer Magnetic Shield Set #4 | 20d | 2011-04-01 | 2011-04-28 | 131133018D | 143d | 108d | MECH TECH [40 h]; MECH DES [8 h]; MECH ENG [8 h] | 2,639.84 | HOGAN J | 1 | 1 | JOHN H | 08-050 |  | 10-027 | 10-064 |  | 11-012 | 11-051 | 12-018F |  |  | 09-017 | 12-028F | 10-066 |  |  |  |
| 131133060 |  | Receive & Insp Inner Magnetic Shield Set #9 | 20d | 2011-05-02 | 2011-05-27 | 131133017G | 421d | 275d | MECH TECH [40 h]; MECH DES [8 h]; MECH ENG [8 h] | 2,639.84 | HOGAN J | 1 | 1 | JOHN H | 08-050 |  | 10-027 | 10-064 |  |  |  | 12-018F |  |  | 09-017 | 12-028F | 10-066 |  |  |  |
| 131133090 |  | Receive & Insp Outer Magnetic Shield Set #5 | 20d | 2011-05-02 | 2011-05-27 | 131133018F | 182d | 147d | MECH DES [8 h]; MECH ENG [8 h]; MECH TECH [40 h] | 2,639.84 | HOGAN J | 1 | 1 | JOHN H | 08-050 |  | 10-027 | 10-064 |  | 11-012 | 11-051 | 12-018F |  |  | 09-017 | 12-028F | 10-066 |  |  |  |
| 131133065 |  | Receive & Insp Inner Magnetic Shield Set #10 | 20d | 2011-06-01 | 2011-06-28 | 131133017H | 435d | 294d | MECH ENG [8 h]; MECH TECH [40 h]; MECH DES [8 h] | 2,639.84 | HOGAN J | 1 | 1 | JOHN H | 08-050 |  | 10-027 | 10-064 |  |  |  | 12-018F |  |  | 09-017 | 12-028F | 10-066 |  |  |  |
| 131133095 |  | Receive & Insp Outer Magnetic Shield Set #6 | 20d | 2011-06-01 | 2011-06-28 | 131133018G | 234d | 142d | MECH DES [8 h]; MECH ENG [8 h]; MECH TECH [40 h] | 2,639.84 | HOGAN J | 1 | 1 | JOHN H | 08-050 |  | 10-027 | 10-064 |  | 11-012 | 11-051 | 12-018F |  |  | 09-017 |  | 10-066 |  |  |  |
| 131133100 |  | Receive & Insp Outer Magnetic Shield Set #7 | 20d | 2011-07-01 | 2011-07-29 | 131133018H | 310d | 148d | MECH DES [8 h]; MECH TECH [40 h]; MECH ENG [8 h] | 2,639.84 | HOGAN J | 1 | 1 | JOHN H | 08-050 |  | 10-027 | 10-064 |  |  | 11-051 | 12-018F |  |  | 09-017 | 12-028F | 10-066 |  |  |  |
| 131133105 |  | Receive & Insp Outer Magnetic Shield Set #8 | 20d | 2011-08-01 | 2011-08-26 | 131133018J | 358d | 217d | MECH ENG [8 h]; MECH TECH [40 h]; MECH DES [8 h] | 2,639.84 | HOGAN J | 1 | 1 | JOHN H | 08-050 |  | 10-027 | 10-064 |  |  | 11-051 | 12-018F |  |  | 09-017 | 12-028F | 10-066 |  |  |  |
| 131133110 |  | Receive & Insp Outer Magnetic Shield Set #9 | 20d | 2011-09-01 | 2011-09-29 | 131133018K | 379d | 233d | MECH TECH [40 h]; MECH DES [8 h]; MECH ENG [8 h] | 2,639.84 | HOGAN J | 1 | 1 | JOHN H | 08-050 |  | 10-027 | 10-064 |  |  | 11-051 | 12-018F |  |  | 09-017 | 12-028F | 10-066 |  |  |  |
| 131133115 |  | Receive & Insp Outer Magnetic Shield Set #10 FY11 | 4d | 2011-09-27 | 2011-09-30 | 131133018L | 392d | 0d | MECH TECH [8 h]; MECH DES [1.6 h]; MECH ENG [1.6 h] | 527.97 | HOGAN J | 1 | 1 | JOHN H | 08-050 |  | 10-027 | 10-064 |  |  | 11-051 | 12-018F |  |  | 09-017 | 12-028F | 10-066 | 12-001 |  |  |
| 131133115a |  | Receive & Insp Outer Magnetic Shield Set #10 FY12 | 16d | 2011-10-03 | 2011-10-24 | 131133115 | 392d | 251d | MECH DES [6.4 h]; MECH ENG [6.4 h]; MECH TECH [32 h] | 2,179.14 | HOGAN J | 1 | 1 | JOHN H | 08-050 |  | 10-027 | 10-064 |  |  | 11-051 | 12-018F |  |  | 09-017 | 12-028F | 10-066 | 12-001 |  |  |
| 131133130LOE |  | SOTR Oversight FY12 | 16d | 2011-10-03 | 2011-10-24 | 131133125LOE | 392d | 251d | MECH ENG [20 h] | 1,402.4 | HOGAN J | 1 | 1 | JOHN H | 08-050 |  | 10-027 | 10-064 |  |  | 11-051 | 12-018F |  |  | 09-017 | 12-028F | 10-066 |  |  |  |
| 131133135 |  | Re-Baseline Actuals Adjustment | 1d | 2013-08-30 | 2013-08-30 | 9-130M FS+227d | 20d |  | PROCUREMENT>$50K 69 NO ESCALATION | 103,024.98 | HOGAN J | 1 | 1 | JOHN H |  |  |  |  |  |  |  |  |  |  |  |  |  |  | 13-014 | ADJ |

| ID | WBS | Activity | Duration | Start | Finish | Predecessors | Total float | Free float | Resources | Cost | RESP - Responsibility | STRT%COMP for CM EVM | FNSH%COMP for CM EVM | CAM RESPONSIBLE | CR 08-050 | CR 10-027 | CR 10-064 | CR 11-003 | CR 11-051 | CR 12-018 | Advance Purchase Plan > 500K | CR 09-012 | CR 10-001 | CR 09-017 | CR 10-012 | CR 10-066 | CR 11-012 | CR 12-028 | CR 13-014 | ReBaseline Actuals Adjustment | 12 GEV MAJOR PROCUREMENT CATAGORY | CR 10-018 | CR 11-001 |
| --- | --- | --- | --- | --- | --- | --- | --- | --- | --- | --- | --- | --- | --- | --- | --- | --- | --- | --- | --- | --- | --- | --- | --- | --- | --- | --- | --- | --- | --- | --- | --- | --- | --- |
|  | 4 | **1.3.1.1.3.4 INSTRUMENTATION** |  | 2009-04-01 | 2013-08-30 |  |  |  |  |  |  |  |  |  |  |  |  |  |  |  |  |  |  |  |  |  |  |  |  |  |  |  |  |
| 131134010 |  | Proc Instrmenttn | 65d | 2009-04-01 | 2009-07-01 | 9-090M FS+120d | 276d | 0d | MECH DES [20 h] | 876.8 | HOGAN J | 1 | 1 | JOHN H | 08-050 | 10-027 | 10-064 | 11-003 | 11-051 | 12-018F |  |  |  |  |  |  |  |  |  |  |  |  |  |
| 131134012 |  | Vend Fab - Instrmenttn (Phase 1) Labor FY09 | 64d | 2009-07-01 | 2009-09-30 | 131134010 FS-1d | 276d | 0d | ELEC TECH [12.8 h]; MECH ENG [6.4 h]; SR STAFF [6.4 h]; ELEC ENG [6.4 h]; MECH DES [6.4 h] | 2,272.39 | HOGAN J | 1 | 1 | JOHN H | 08-050 | 10-027 | 10-064 | 11-003 | 11-051 | 12-018F | APP | 09-012 | 10-001B |  |  |  |  |  |  |  |  |  |  |
| 131134012c |  | Vend Fab - Instrmenttn (Phase 1) Procurement | 120d | 2009-07-01 | 2009-12-28 | 131134010 FS-1d | 276d | 0d | PROCUREMENT>$50K 69 NO ESCALATION FY10 | 81,139.1 | HOGAN J | 1 | 1 | JOHN H |  | 10-027 | 10-064 | 11-003 | 11-051 | 12-018F | APP |  | 10-001B |  |  |  |  |  |  |  |  |  |  |
| 131134012b |  | Vend Fab - Instrmenttn (Phase 1) Labor FY10 | 56d | 2009-10-01 | 2009-12-28 | 131134012 | 276d | 0d | MECH ENG [5.6 h]; SR STAFF [5.6 h]; ELEC ENG [5.6 h]; MECH DES [5.6 h]; ELEC TECH [11.2 h] | 2,051.72 | HOGAN J | 1 | 1 | JOHN H |  | 10-027 | 10-064 | 11-003 | 11-051 | 12-018F | APP |  | 10-001B |  |  |  |  |  |  |  |  |  |  |
| 131134013 |  | Vend Fab - Instrmenttn (Phase 2) | 120d | 2009-12-29 | 2010-06-18 | 131134012b, 9-100M, 131134012c | 313d | 0d | ELEC TECH [56 h]; MECH ENG [28 h]; MECH DES [28 h]; SR STAFF [28 h]; PROCUREMENT>$50K 69; ELEC ENG [28 h] | 405,622.66 | HOGAN J | 1 | 1 | JOHN H | 08-050 | 10-027 | 10-064 |  | 11-051 | 12-018F | APP |  |  | 09-017 | 10-012 | 10-066 | 11-012 | 12-028F |  |  |  |  |  |
| 131134015 |  | Receive & Insp Instrmenttn (Phase 1) | 20d | 2009-12-29 | 2010-01-27 | 131134012c, 131134012b, 131134010 | 276d | 204d | ELEC ENG [12 h]; ELEC TECH [24 h]; MECH DES [6 h]; SUPPLIES & MATERIALS | 3,709.66 | HOGAN J | 1 | 1 | JOHN H | 08-050 | 10-027 | 10-064 | 11-003 | 11-051 | 12-018F |  |  |  |  |  |  |  |  |  |  |  |  |  |
| 131134016 |  | Receive & Insp Instrmenttn (Phase 2) | 20d | 2010-06-21 | 2010-07-19 | 131134013 | 313d | 0d | ELEC TECH [56 h]; MECH DES [14 h]; SUPPLIES & MATERIALS; ELEC ENG [28 h] | 8,655.87 | HOGAN J | 1 | 1 | JOHN H | 08-050 | 10-027 | 10-064 |  | 11-051 | 12-018F |  |  |  | 09-017 |  | 10-066 | 11-012 | 12-028F |  |  |  |  |  |
| 131134021LOE |  | SOTR Oversight | 64d | 2010-07-01 | 2010-09-30 | 9-100M FS+184d | 343d | 308d | ELEC ENG [200 h]; ELEC TECH [320 h]; MECH DES [80 h] | 30,137.2 | HOGAN J | 1 | 1 | JOHN H | 08-050 | 10-027 | 10-064 |  | 11-051 | 12-018F |  |  |  | 09-017 |  | 10-066 | 11-012 | 12-028F |  |  |  |  |  |
| 131134018 |  | Receive & Insp Instrmenttn (Phase 2) Additinal Hardware | 52d | 2010-07-20 | 2010-09-30 | 131134016 | 313d | 183d | MECH DES [14 h]; SUPPLIES & MATERIALS; ELEC ENG [28 h]; ELEC TECH [56 h] | 8,655.87 | HOGAN J | 1 | 1 | JOHN H | 08-050 | 10-027 | 10-064 |  | 11-051 | 12-018F |  |  |  | 09-017 |  | 10-066 | 11-012 | 12-028F |  |  |  |  |  |
| 131134025 |  | Re-Baseline Actuals Adjustment | 1d | 2013-08-30 | 2013-08-30 | 9-130M FS+227d | 20d |  | PROCUREMENT>$50K 69 NO ESCALATION | 459,231.19 | HOGAN J | 1 | 1 | JOHN H |  |  |  |  |  |  |  |  |  |  |  |  |  |  | 13-014 | ADJ |  |  |  |
|  | 5 | **1.3.1.1.3.5 END CANS** |  | 2009-10-01 | 2013-08-30 |  |  |  |  |  |  |  |  |  |  |  |  |  |  |  |  |  |  |  |  |  |  |  |  |  |  |  |  |
| 131135010 |  | Proc End Cans | 80d | 2009-10-01 | 2010-02-02 | 1211020M10, 9-100M | -25d | 0d | MECH ENG [20 h]; MECH DES [20 h] | 2,221.8 | HOGAN J | 1 | 1 | JOHN H | 08-050 |  |  |  |  |  |  |  |  | 09-017 |  |  |  |  |  |  |  |  |  |
| 131135015 |  | Technical Oversight End Cans Procurement FY10 | 189d | 2010-01-04 | 2010-09-30 | 131135010 FS-21d | 515d | 0d | MECH DES [45.82 h]; SUPPLIES & MATERIALS; TRAVEL; MECH ENG [45.82 h] | 20,822.76 | HOGAN J | 1 | 1 | JOHN H | 08-050 | 10-027 | 10-064 |  | 11-051 | 12-018F | APP |  |  | 09-017 |  | 10-066 |  | 12-028F |  |  | 3113A | 10-018 |  |
| 131135015B |  | Vend Fab End Cans - Submittal of Project Q.A. Plan | 19d | 2010-01-04 | 2010-01-29 | 131135010 FS-21d | 114d | 0d | PROCUREMENT<$50K 60 NO ESCALATION; PROCUREMENT>$50K 69 NO ESCALATION | 67,645 | HOGAN J | 1 | 1 | JOHN H |  | 10-027 | 10-064 | 11-003 | 11-051 |  | APP |  |  |  |  |  |  |  |  |  | 3113A | 10-018 |  |
| 131135015C |  | Vend Fab End Cans - Material P.O. for End Can sets 1-3 | 83d | 2010-01-04 | 2010-04-30 | 131135015B FS-19d | 114d | 0d | PROCUREMENT>$50K 69 NO ESCALATION | 174,599 | HOGAN J | 1 | 1 | JOHN H |  | 10-027 | 10-064 | 11-003 | 11-051 |  | APP |  |  |  |  |  |  |  |  |  | 3113A | 10-018 |  |
| 131135015D |  | Vend Fab End Cans - Material Receipt for End Can sets 4-6 | 168d | 2010-01-04 | 2010-08-31 | 131135015C FS-83d | 114d | 0d | PROCUREMENT>$50K 69 NO ESCALATION | 158,211 | HOGAN J | 1 | 1 | JOHN H |  | 10-027 | 10-064 | 11-003 | 11-051 |  | APP |  |  |  |  |  |  |  |  |  | 3113A | 10-018 |  |
| 131135015F |  | Vend Fab End Cans - Material P.O. for End Can sets 7-8 | 210d | 2010-01-04 | 2010-10-29 | 131135015D FS-168d | 114d | 0d | PROCUREMENT>$50K 69 NO ESCALATION | 158,211 | HOGAN J | 1 | 1 | JOHN H |  | 10-027 | 10-064 | 11-003 | 11-051 |  | APP |  |  |  |  |  |  |  |  |  | 3113A | 10-018 |  |
| 131135015G |  | Vend Fab End Cans - Material Receipt for End Can sets 9-10 | 247d | 2010-01-04 | 2010-12-30 | 131135015F FS-210d | 114d | 0d | PROCUREMENT>$50K 69 NO ESCALATION | 158,211 | HOGAN J | 1 | 1 | JOHN H |  | 10-027 | 10-064 | 11-003 | 11-051 |  | APP |  |  |  |  |  |  |  |  |  | 3113A | 10-018 |  |
| 131135015H |  | Vend Fab End Cans - Delivery of Set #1 | 146d | 2010-01-04 | 2010-07-30 | 131135015G FS-247d | 114d | 0d | PROCUREMENT>$50K 69 NO ESCALATION | 136,921 | HOGAN J | 1 | 1 | JOHN H |  | 10-027 | 10-064 | 11-003 | 11-051 |  | APP |  |  |  |  |  |  |  |  |  | 3113A | 10-018 |  |
| 131135015J |  | Vend Fab End Cans - Delivery of Set #2 | 189d | 2010-01-04 | 2010-09-30 | 131135015H FS-146d | 114d | 0d | PROCUREMENT>$50K 69 NO ESCALATION | 55,456 | HOGAN J | 1 | 1 | JOHN H |  | 10-027 | 10-064 | 11-003 | 11-051 |  | APP |  |  |  |  |  | 11-012 |  |  |  | 3113A | 10-018 |  |
| 131135015K |  | Vend Fab End Cans - Delivery of Set #3 | 189d | 2010-01-04 | 2010-09-30 | 131135015J FS-189d | 182d | 0d | PROCUREMENT>$50K 69 NO ESCALATION | 55,456 | HOGAN J | 1 | 1 | JOHN H |  | 10-027 | 10-064 | 11-003 | 11-051 | 12-018F | APP |  |  |  |  |  | 11-012 | 12-028F |  |  | 3113A | 10-018 |  |
| 131135015N |  | Vend Fab End Cans - Delivery of Set #4 | 230d | 2010-01-04 | 2010-11-30 | 131135015K FS-189d | 182d | 0d | PROCUREMENT>$50K 69 NO ESCALATION | 55,456 | HOGAN J | 1 | 1 | JOHN H |  | 10-027 | 10-064 |  | 11-051 | 12-018F | APP |  |  |  |  | 10-066 | 11-012 | 12-028F |  |  | 3113A | 10-018 |  |
| 131135015O |  | Vend Fab End Cans - Delivery of Set #5 | 230d | 2010-01-04 | 2010-11-30 | 131135015N FS-230d | 242d | 0d | PROCUREMENT>$50K 69 NO ESCALATION | 55,456 | HOGAN J | 1 | 1 | JOHN H |  | 10-027 | 10-064 |  | 11-051 | 12-018F | APP |  |  |  |  | 10-066 | 11-012 | 12-028F |  |  | 3113A | 10-018 |  |
| 131135015P |  | Vend Fab End Cans - Delivery of Set #6 | 248d | 2010-01-04 | 2010-12-31 | 131135015O FS-230d | 297d | 0d | PROCUREMENT>$50K 69 NO ESCALATION | 55,456 | HOGAN J | 1 | 1 | JOHN H |  | 10-027 | 10-064 |  | 11-051 | 12-018F | APP |  |  |  |  | 10-066 | 11-012 |  |  |  | 3113A | 10-018 |  |
| 131135015Q |  | Vend Fab End Cans - Delivery of Set #7 | 267d | 2010-01-05 | 2011-02-01 | 131135015P FS-247d | 375d | 0d | PROCUREMENT>$50K 69 NO ESCALATION | 55,456 | HOGAN J | 1 | 1 | JOHN H |  | 10-027 | 10-064 |  | 11-051 | 12-018F | APP |  |  |  |  | 10-066 |  | 12-028F |  |  | 3113A | 10-018 |  |
| 131135015R |  | Vend Fab End Cans - Delivery of Set #8 | 267d | 2010-01-05 | 2011-02-01 | 131135015Q FS-267d | 443d | 0d | PROCUREMENT>$50K 69 NO ESCALATION | 55,456 | HOGAN J | 1 | 1 | JOHN H |  | 10-027 | 10-064 |  | 11-051 | 12-018F | APP |  |  |  |  | 10-066 |  | 12-028F |  |  | 3113A | 10-018 |  |
| 131135015S |  | Vend Fab End Cans - Delivery of Set #9 | 309d | 2010-01-05 | 2011-04-01 | 131135015R FS-267d | 445d | 0d | PROCUREMENT>$50K 69 NO ESCALATION | 55,456 | HOGAN J | 1 | 1 | JOHN H |  | 10-027 | 10-064 |  | 11-051 | 12-018F | APP |  |  |  |  | 10-066 |  | 12-028F |  |  | 3113A | 10-018 |  |
| 131135015T |  | Vend Fab End Cans - Delivery of Set #10 | 330d | 2010-01-05 | 2011-05-02 | 131135015S FS-309d | 454d | 0d | PROCUREMENT>$50K 69 NO ESCALATION | 55,456 | HOGAN J | 1 | 1 | JOHN H |  | 10-027 | 10-064 |  | 11-051 | 12-018F | APP |  |  |  |  | 10-066 |  | 12-028F |  |  | 3113A | 10-018 |  |
| 131135016 |  | Electronic Valve Actuators | 5d | 2010-07-01 | 2010-07-08 | 131135010 FS+104d | 655d | 201d | PROCUREMENT<$50K 60 | 25,000 | HOGAN J | 1 | 1 | JOHN H |  | 10-027 | 10-064 |  | 11-051 | 12-018F | APP |  |  |  |  | 10-066 |  | 12-028F |  |  | 3113A | 10-018 |  |
| 131135017 |  | Additional End Can Hardware | 5d | 2010-07-01 | 2010-07-08 | 131135010 FS+104d | 655d | 201d | PROCUREMENT>$50K 69 NO ESCALATION | 25,000 | HOGAN J | 1 | 1 | JOHN H |  | 10-027 | 10-064 |  | 11-051 | 12-018F | APP |  |  |  |  | 10-066 |  | 12-028F |  |  | 3113A | 10-018 |  |
| 131135020 |  | Receive & Insp End Cans Set #1 FY10 | 43d | 2010-08-02 | 2010-09-30 | 131135015H | 127d | 0d | MECH ENG [14.33 h]; MECH TECH [57.33 h]; SUPPLIES & MATERIALS; MECH DES [5.73 h] | 4,068.29 | HOGAN J | 1 | 1 | JOHN H | 08-050 | 10-027 | 10-064 | 11-003 | 11-051 | 12-018F |  |  |  | 09-017 |  |  |  |  |  |  |  | 10-018 | 11-001 |
| 131135015A |  | Technical Oversight End Cans Procurement FY11 | 141d | 2010-10-01 | 2011-04-29 | 131135015 | 515d | 61d | MECH ENG [120 h]; MECH DES [34.18 h]; SUPPLIES & MATERIALS; TRAVEL | 21,860.96 | HOGAN J | 1 | 1 | JOHN H |  | 10-027 | 10-064 |  | 11-051 | 12-018F | APP |  |  |  |  | 10-066 |  | 12-028F |  |  | 3113A | 10-018 |  |
| 131135020a |  | Receive & Insp End Cans Set #1 FY11 | 17d | 2010-10-01 | 2010-10-25 | 131135020 | 127d | 55d | MECH TECH [22.67 h]; SUPPLIES & MATERIALS; MECH DES [2.27 h]; MECH ENG [5.67 h] | 1,660.39 | HOGAN J | 1 | 1 | JOHN H | 08-050 | 10-027 | 10-064 | 11-003 | 11-051 | 12-018F |  |  |  | 09-017 |  |  |  |  |  |  |  | 10-018 | 11-001 |
| 131135025 |  | Receive & Insp End Cans Set #2 | 60d | 2010-10-01 | 2011-01-04 | 131135015J | 114d | 77d | SUPPLIES & MATERIALS; MECH TECH [80 h]; MECH DES [8 h]; MECH ENG [20 h] | 5,858.34 | HOGAN J | 1 | 1 | JOHN H | 08-050 | 10-027 | 10-064 | 11-003 | 11-051 |  |  |  |  | 09-017 |  |  | 11-012 |  |  |  |  | 10-018 |  |
| 131135030 |  | Receive & Insp End Cans Set #3 | 60d | 2010-10-01 | 2011-01-04 | 131135015K | 207d | 93d | SUPPLIES & MATERIALS; MECH TECH [80 h]; MECH DES [8 h]; MECH ENG [20 h] | 5,858.34 | HOGAN J | 1 | 1 | JOHN H | 08-050 | 10-027 | 10-064 | 11-003 | 11-051 | 12-018F |  |  |  | 09-017 |  |  | 11-012 | 12-028F |  |  |  | 10-018 |  |
| 131135035 |  | Receive & Insp End Cans Set #4 | 60d | 2010-12-01 | 2011-03-04 | 131135015N | 182d | 147d | MECH DES [8 h]; MECH ENG [20 h]; SUPPLIES & MATERIALS; MECH TECH [80 h] | 5,858.34 | HOGAN J | 1 | 1 | JOHN H |  | 10-027 | 10-064 |  | 11-051 | 12-018F |  |  |  |  |  | 10-066 | 11-012 | 12-028F |  |  |  | 10-018 |  |
| 131135040 |  | Receive & Insp End Cans Set #5 | 60d | 2010-12-01 | 2011-03-04 | 131135015O | 242d | 207d | MECH DES [8 h]; MECH ENG [20 h]; SUPPLIES & MATERIALS; MECH TECH [80 h] | 5,858.34 | HOGAN J | 1 | 1 | JOHN H |  | 10-027 | 10-064 |  | 11-051 | 12-018F |  |  |  |  |  | 10-066 | 11-012 | 12-028F |  |  |  | 10-018 |  |
| 131135045 |  | Receive & Insp End Cans Set #6 | 60d | 2011-01-04 | 2011-03-30 | 131135015P | 297d | 205d | MECH ENG [20 h]; SUPPLIES & MATERIALS; MECH TECH [80 h]; MECH DES [8 h] | 5,858.34 | HOGAN J | 1 | 1 | JOHN H |  | 10-027 | 10-064 |  | 11-051 | 12-018F |  |  |  |  |  | 10-066 | 11-012 |  |  |  |  | 10-018 |  |
| 131135050 |  | Receive & Insp End Cans Set #7 | 60d | 2011-02-02 | 2011-04-27 | 131135015Q | 375d | 213d | MECH ENG [20 h]; SUPPLIES & MATERIALS; MECH TECH [80 h]; MECH DES [8 h] | 5,858.34 | HOGAN J | 1 | 1 | JOHN H |  | 10-027 | 10-064 |  | 11-051 | 12-018F |  |  |  |  |  | 10-066 |  | 12-028F |  |  |  | 10-018 |  |
| 131135055 |  | Receive & Insp End Cans Set #8 | 60d | 2011-02-02 | 2011-04-27 | 131135015R | 443d | 302d | MECH TECH [80 h]; MECH DES [8 h]; MECH ENG [20 h]; SUPPLIES & MATERIALS | 5,858.34 | HOGAN J | 1 | 1 | JOHN H |  | 10-027 | 10-064 |  | 11-051 | 12-018F |  |  |  |  |  | 10-066 |  | 12-028F |  |  |  | 10-018 |  |
| 131135060 |  | Receive & Insp End Cans Set #9 | 60d | 2011-04-04 | 2011-06-27 | 131135015S | 445d | 299d | MECH DES [8 h]; MECH ENG [20 h]; SUPPLIES & MATERIALS; MECH TECH [80 h] | 5,858.34 | HOGAN J | 1 | 1 | JOHN H |  | 10-027 | 10-064 |  | 11-051 | 12-018F |  |  |  |  |  | 10-066 |  | 12-028F |  |  |  | 10-018 |  |
| 131135065 |  | Receive & Insp End Cans Set #10 | 60d | 2011-05-03 | 2011-07-27 | 131135015A FS-60d, 131135016, 131135017, 131135015T | 454d | 313d | MECH TECH [80 h]; MECH DES [8 h]; MECH ENG [20 h]; SUPPLIES & MATERIALS | 5,858.34 | HOGAN J | 1 | 1 | JOHN H |  | 10-027 | 10-064 |  | 11-051 | 12-018F |  |  |  |  |  | 10-066 |  | 12-028F |  |  |  | 10-018 |  |
| 131135070 |  | Re-Baseline Actuals Adjustment | 1d | 2013-08-30 | 2013-08-30 | 9-130M FS+227d | 20d |  | PROCUREMENT>$50K 69 NO ESCALATION | -11,415.67 | HOGAN J | 1 | 1 | JOHN H |  |  |  |  |  |  |  |  |  |  |  |  |  |  | 13-014 | ADJ |  |  |  |

| ID | WBS | Activity | Duration | Start | Finish | Predecessors | Total float | Free float | Resources | Cost | RESP - Responsibility | STRT%COMP for CM EVM | FNSH%COMP for CM EVM | CAM RESPONSIBLE | CR 08-050 | Advance Purchase Plan > 500K | 12 GEV MAJOR PROCUREMENT CATAGORY | CR 09-017 | CR 10-004 | CR 10-027 | CR 10-064 | CR 11-003 | CR 11-012 | CR 11-051 | CR 12-018 | CR 12-028 | CR 10-066 | CR 11-001 | CR 10-018 | CR 13-014 | ReBaseline Actuals Adjustment |
| --- | --- | --- | --- | --- | --- | --- | --- | --- | --- | --- | --- | --- | --- | --- | --- | --- | --- | --- | --- | --- | --- | --- | --- | --- | --- | --- | --- | --- | --- | --- | --- |
|  | 6 | **1.3.1.1.3.6 VACUUM VESSELS** |  | 2009-11-02 | 2013-08-30 |  |  |  |  |  |  |  |  |  |  |  |  |  |  |  |  |  |  |  |  |  |  |  |  |  |  |
| 131136010 |  | Proc Vac Vessels | 1d | 2009-11-02 | 2009-11-02 | 9-100M FS+22d | 17d | 0d | MECH ENG [20 h]; MECH DES [20 h] | 2,221.8 | HOGAN J | 1 | 1 | JOHN H | 08-050 |  |  |  |  |  |  |  |  |  |  |  |  |  |  |  |  |
| 131136016 |  | Vend Fab - Vac Vessels Peg Point #1 Materials | 39d | 2009-11-25 | 2010-01-29 | 9-100M FS+39d | 174d | 0d | PROCUREMENT>$50K 69; PROCUREMENT<$50K 60 NO ESCALATION | 184,500 | HOGAN J | 1 | 1 | JOHN H | 08-050 | APP | 3113B | 09-017 | 10-004 | 10-027 | 10-064 | 11-003 | 11-012 | 11-051 |  |  |  |  |  |  |  |
| 131136016a |  | Vend Fab - Vac Vessels Peg Point #2 Acceptance of First Article | 103d | 2009-11-25 | 2010-04-30 | 131136016 FS-39d | 174d | 0d | PROCUREMENT>$50K 69 NO ESCALATION | 61,812 | HOGAN J | 1 | 1 | JOHN H |  | APP | 3113B |  | 10-004 | 10-027 | 10-064 | 11-003 | 11-012 | 11-051 |  |  |  |  |  |  |  |
| 131136016b |  | Vend Fab - Vac Vessels Peg Point #4 Completion of Production components prior to Welding | 103d | 2009-11-25 | 2010-04-30 | 131136016a FS-103d | 174d | 0d | PROCUREMENT>$50K 69 NO ESCALATION | 162,925 | HOGAN J | 1 | 1 | JOHN H |  | APP | 3113B |  | 10-004 | 10-027 | 10-064 | 11-003 | 11-012 | 11-051 |  |  |  |  |  |  |  |
| 131136016c |  | Vend Fab - Vac Vessels Peg Point #3 First Article Shipped | 145d | 2009-11-25 | 2010-06-30 | 131136016b FS-103d | 174d | 0d | PROCUREMENT>$50K 69 NO ESCALATION | 15,528 | HOGAN J | 1 | 1 | JOHN H |  | APP | 3113B |  | 10-004 | 10-027 | 10-064 | 11-003 | 11-012 | 11-051 |  |  |  |  |  |  |  |
| 131136016d |  | Vend Fab - Vac Vessels Peg Point #5 Vacuum Vessel Assembly #2 Shipped | 188d | 2009-11-25 | 2010-08-31 | 131136016c FS-145d | 174d | 0d | PROCUREMENT>$50K 69 NO ESCALATION | 42,313 | HOGAN J | 1 | 1 | JOHN H |  | APP | 3113B |  | 10-004 | 10-027 | 10-064 | 11-003 | 11-012 | 11-051 |  |  |  |  |  |  |  |
| 131136016f |  | Vend Fab - Vac Vessels Peg Point #6 Vacuum Vessel Assembly #3 Shipped | 209d | 2009-11-25 | 2010-09-30 | 131136016d FS-188d | 242d | 0d | PROCUREMENT>$50K 69 NO ESCALATION | 42,313 | HOGAN J | 1 | 1 | JOHN H |  | APP | 3113B |  | 10-004 | 10-027 | 10-064 | 11-003 | 11-012 | 11-051 | 12-018F | 12-028F |  |  |  |  |  |
| 131136016g |  | Vend Fab - Vac Vessels Peg Point #7 Vacuum Vessel Assembly #4 Shipped | 230d | 2009-11-25 | 2010-10-29 | 131136016f FS-209d | 242d | 0d | PROCUREMENT>$50K 69 NO ESCALATION | 42,313 | HOGAN J | 1 | 1 | JOHN H |  | APP | 3113B |  | 10-004 | 10-027 | 10-064 |  | 11-012 | 11-051 | 12-018F | 12-028F | 10-066 |  |  |  |  |
| 131136016h |  | Vend Fab - Vac Vessels Peg Point #8 Vacuum Vessel Assembly #5 Shipped | 250d | 2009-11-25 | 2010-11-30 | 131136016g FS-230d | 279d | 0d | PROCUREMENT>$50K 69 NO ESCALATION | 42,313 | HOGAN J | 1 | 1 | JOHN H |  | APP | 3113B |  | 10-004 | 10-027 | 10-064 |  | 11-012 | 11-051 | 12-018F | 12-028F | 10-066 |  |  |  |  |
| 131136016j |  | Vend Fab - Vac Vessels Peg Point #9 Vacuum Vessel Assembly #6 Shipped | 287d | 2009-11-25 | 2011-01-31 | 131136016h FS-250d | 319d | 0d | PROCUREMENT>$50K 69 NO ESCALATION | 42,313 | HOGAN J | 1 | 1 | JOHN H |  | APP | 3113B |  | 10-004 | 10-027 | 10-064 |  | 11-012 | 11-051 | 12-018F |  | 10-066 |  |  |  |  |
| 131136016k |  | Vend Fab - Vac Vessels Peg Point #10 Vacuum Vessel Assembly #7 Shipped | 306d | 2009-11-25 | 2011-02-28 | 131136016j FS-287d | 394d | 0d | PROCUREMENT>$50K 69 NO ESCALATION | 42,313 | HOGAN J | 1 | 1 | JOHN H |  | APP | 3113B |  | 10-004 | 10-027 | 10-064 |  |  | 11-051 | 12-018F | 12-028F | 10-066 |  |  |  |  |
| 131136016n |  | Vend Fab - Vac Vessels Peg Point #11 Vacuum Vessel Assembly #8 Shipped | 329d | 2009-11-25 | 2011-03-31 | 131136016k FS-306d | 441d | 0d | PROCUREMENT>$50K 69 NO ESCALATION | 42,313 | HOGAN J | 1 | 1 | JOHN H |  | APP | 3113B |  | 10-004 | 10-027 | 10-064 |  |  | 11-051 | 12-018F | 12-028F | 10-066 |  |  |  |  |
| 131136016o |  | Vend Fab - Vac Vessels Peg Point #12 Vacuum Vessel Assembly #9 Shipped | 350d | 2009-11-25 | 2011-04-29 | 131136016n FS-329d | 464d | 0d | PROCUREMENT>$50K 69 NO ESCALATION | 42,313 | HOGAN J | 1 | 1 | JOHN H |  | APP | 3113B |  | 10-004 | 10-027 | 10-064 |  |  | 11-051 | 12-018F | 12-028F | 10-066 |  |  |  |  |
| 131136016p |  | Vend Fab - Vac Vessels Peg Point #13 Vacuum Vessel Assembly #10 Shipped | 371d | 2009-11-25 | 2011-05-31 | 131136016o FS-350d | 472d | 0d | PROCUREMENT>$50K 69 NO ESCALATION | 42,313 | HOGAN J | 1 | 1 | JOHN H |  | APP | 3113B |  | 10-004 | 10-027 | 10-064 |  |  | 11-051 | 12-018F | 12-028F | 10-066 |  |  |  |  |
| 131136015 |  | Vend Fab - Vac Vessels Lot #1 Original Labor FY10 | 146d | 2010-03-08 | 2010-09-30 | 9-100M FS+102d | 197d | 0d | SUPPLIES & MATERIALS; MECH ENG [77.87 h]; TRAVEL; SR STAFF [38.93 h]; MECH DES [77.87 h] | 39,518.95 | HOGAN J | 1 | 1 | JOHN H | 08-050 | APP | 3113B | 09-017 | 10-004 | 10-027 | 10-064 | 11-003 |  | 11-051 | 12-018F |  |  | 11-001 |  |  |  |
| 131136017 |  | Vend Fab Insulating Vac Components and Hardware | 5d | 2010-07-01 | 2010-07-08 | 131135010 FS+104d | 693d | 221d | PROCUREMENT<$50K 60 | 40,000 | HOGAN J | 1 | 1 | JOHN H |  | APP | 3113A |  |  | 10-027 | 10-064 |  |  | 11-051 | 12-018F | 12-028F | 10-066 |  | 10-018 |  |  |
| 131136020 |  | Receive & Insp Vac Vessels First Article | 21d | 2010-07-01 | 2010-07-30 | 131136016c, 131136015a FS-69d | 196d | 22d | MECH DES [16 h]; MECH ENG [24 h]; MECH TECH [40 h]; SUPPLIES & MATERIALS | 5,020.21 | HOGAN J | 1 | 1 | JOHN H | 08-050 |  |  | 09-017 | 10-004 | 10-027 | 10-064 | 11-003 |  | 11-051 | 12-018F |  |  |  |  |  |  |
| 131136025 |  | Receive & Insp Vac Vessel Assembly #2 | 21d | 2010-09-01 | 2010-09-30 | 131136020, 131136016d | 174d | 0d | MECH TECH [40 h]; MECH DES [16 h]; MECH ENG [16 h]; SUPPLIES & MATERIALS | 3,697.04 | HOGAN J | 1 | 1 | JOHN H | 08-050 |  |  | 09-017 | 10-004 | 10-027 | 10-064 | 11-003 | 11-012 | 11-051 |  |  |  |  |  |  |  |
| 131136015a |  | Vend Fab - Vac Vessels Lot #1 Original Labor FY11 | 4d | 2010-10-01 | 2010-10-06 | 131136015 | 197d | 1d | SUPPLIES & MATERIALS; MECH ENG [2.13 h]; TRAVEL; SR STAFF [1.07 h]; MECH DES [2.13 h] | 1,117.23 | HOGAN J | 1 | 1 | JOHN H | 08-050 | APP | 3113B | 09-017 | 10-004 | 10-027 | 10-064 | 11-003 |  | 11-051 | 12-018F |  |  | 11-001 |  |  |  |
| 131136030 |  | Receive & Insp Vac Vessels Assembly #3 | 21d | 2010-10-01 | 2010-10-29 | 131136025, 131136016f | 242d | 0d | MECH DES [8 h]; MECH TECH [40 h]; MECH ENG [8 h]; SUPPLIES & MATERIALS | 2,897.82 | HOGAN J | 1 | 1 | JOHN H | 08-050 |  |  | 09-017 | 10-004 | 10-027 | 10-064 | 11-003 | 11-012 | 11-051 | 12-018F | 12-028F |  |  |  |  |  |
| 131136035 |  | Receive & Insp Vac Vessels Assembly #4 | 20d | 2010-11-01 | 2010-11-30 | 131136030, 131136016g | 242d | 0d | MECH DES [8 h]; MECH TECH [40 h]; MECH ENG [8 h]; SUPPLIES & MATERIALS | 2,897.82 | HOGAN J | 1 | 1 | JOHN H |  |  |  |  | 10-004 | 10-027 | 10-064 |  | 11-012 | 11-051 | 12-018F | 12-028F | 10-066 |  |  |  |  |
| 131136040 |  | Receive & Insp Vac Vessels Assembly #5 | 23d | 2010-12-01 | 2011-01-10 | 131136016h, 131136035 | 279d | 14d | MECH DES [4 h]; MECH TECH [40 h]; MECH ENG [4 h]; SUPPLIES & MATERIALS | 2,439.3 | HOGAN J | 1 | 1 | JOHN H |  |  |  |  | 10-004 | 10-027 | 10-064 |  | 11-012 | 11-051 | 12-018F | 12-028F | 10-066 |  |  |  |  |
| 131136045 |  | Receive & Insp Vac Vessels Assembly #6 | 19d | 2011-02-01 | 2011-02-28 | 131136016j, 131136040 | 319d | 0d | MECH ENG [4 h]; SUPPLIES & MATERIALS; MECH DES [4 h]; MECH TECH [40 h] | 2,439.3 | HOGAN J | 1 | 1 | JOHN H |  |  |  |  | 10-004 | 10-027 | 10-064 |  | 11-012 | 11-051 | 12-018F |  | 10-066 |  |  |  |  |
| 131136050 |  | Receive & Insp Vac Vessels Assembly #7 | 23d | 2011-03-01 | 2011-03-31 | 131136016k, 131136045 | 394d | 0d | MECH TECH [40 h]; SUPPLIES & MATERIALS; MECH DES [4 h]; MECH ENG [4 h] | 2,439.3 | HOGAN J | 1 | 1 | JOHN H |  |  |  |  | 10-004 | 10-027 | 10-064 |  |  | 11-051 | 12-018F | 12-028F | 10-066 |  |  |  |  |
| 131136055 |  | Receive & Insp Vac Vessels Assembly #8 | 21d | 2011-04-01 | 2011-04-29 | 131136050, 131136016n | 441d | 0d | MECH DES [4 h]; MECH TECH [40 h]; MECH ENG [4 h]; SUPPLIES & MATERIALS | 2,439.3 | HOGAN J | 1 | 1 | JOHN H |  |  |  |  | 10-004 | 10-027 | 10-064 |  |  | 11-051 | 12-018F | 12-028F | 10-066 |  |  |  |  |
| 131136060 |  | Receive & Insp Vac Vessels Assembly #9 | 21d | 2011-05-02 | 2011-05-31 | 131136055, 131136016o | 464d | 0d | MECH DES [4 h]; MECH TECH [40 h]; SUPPLIES & MATERIALS; MECH ENG [4 h] | 2,439.3 | HOGAN J | 1 | 1 | JOHN H |  |  |  |  | 10-004 | 10-027 | 10-064 |  |  | 11-051 | 12-018F | 12-028F | 10-066 |  |  |  |  |
| 131136065 |  | Receive & Insp Vac Vessels Assembly #10 | 22d | 2011-06-01 | 2011-06-30 | 131136060, 131136016p, 131136017 | 472d | 331d | SUPPLIES & MATERIALS; MECH DES [4 h]; MECH TECH [40 h]; MECH ENG [4 h] | 2,439.3 | HOGAN J | 1 | 1 | JOHN H |  |  |  |  | 10-004 | 10-027 | 10-064 |  |  | 11-051 | 12-018F | 12-028F | 10-066 |  |  |  |  |
| 131136070 |  | Re-Baseline Actuals Adjustment | 1d | 2013-08-30 | 2013-08-30 | 9-130M FS+227d | 20d |  | PROCUREMENT>$50K 69 NO ESCALATION | 29,991.66 | HOGAN J | 1 | 1 | JOHN H |  |  |  |  |  |  |  |  |  |  |  |  |  |  |  | 13-014 | ADJ |

| ID | WBS | Activity | Duration | Start | Finish | Predecessors | Total float | Free float | Resources | Cost | RESP - Responsibility | STRT%COMP for CM EVM | FNSH%COMP for CM EVM | CAM RESPONSIBLE | CR 08-050 | CR 09-017 | CR 09-042 | CR 10-001 | CR 10-027 | CR 10-064 | CR 11-003 | CR 11-051 | Advance Purchase Plan > 500K | 12 GEV MAJOR PROCUREMENT CATAGORY | CR 12-018 | CR 13-014 | ReBaseline Actuals Adjustment | CR 10-012 | CR 10-012A | CR 10-066 | CR 11-012 | CR 12-028 | CR 11-001 |
| --- | --- | --- | --- | --- | --- | --- | --- | --- | --- | --- | --- | --- | --- | --- | --- | --- | --- | --- | --- | --- | --- | --- | --- | --- | --- | --- | --- | --- | --- | --- | --- | --- | --- |
|  | 7 | **1.3.1.1.3.7 BEAM PIPES** |  | 2009-09-25 | 2013-08-30 |  |  |  |  |  |  |  |  |  |  |  |  |  |  |  |  |  |  |  |  |  |  |  |  |  |  |  |  |
| 131137010 |  | Proc Beam Pipes Labor FY09 | 4d | 2009-09-25 | 2009-09-30 | 9-100M FS-4d | 176d | 0d | MECH DES [0.63 h]; MECH ENG [0.79 h] | 78.03 | HOGAN J | 1 | 1 | JOHN H | 08-050 | 09-017 | 09-042 | 10-001B | 10-027 | 10-064 | 11-003 | 11-051 |  |  |  |  |  |  |  |  |  |  |  |
| 131137012 |  | Vend Fab - Cold Valves 1-4 | 101d | 2009-09-25 | 2010-02-26 | 9-100M FS-4d | 144d | 0d | PROCUREMENT<$50K 60 NO ESCALATION; PROCUREMENT>$50K 69 NO ESCALATION | 79,980 | HOGAN J | 1 | 1 | JOHN H | 08-050 | 09-017 | 09-042 |  | 10-027 | 10-064 | 11-003 | 11-051 | APP | 3113C |  |  |  |  |  |  |  |  |  |
| 131137013 |  | Vend Fab - Cold Valves 5-8 | 124d | 2009-09-25 | 2010-03-31 | 9-100M FS-4d | 144d | 0d | PROCUREMENT>$50K 69 NO ESCALATION; PROCUREMENT<$50K 60 NO ESCALATION | 79,980 | HOGAN J | 1 | 1 | JOHN H | 08-050 | 09-017 | 09-042 |  | 10-027 | 10-064 | 11-003 | 11-051 | APP | 3113C |  |  |  |  |  |  |  |  |  |
| 131137014 |  | Vend Fab - Cold Valves 9-12 | 124d | 2009-09-25 | 2010-03-31 | 9-100M FS-4d | 144d | 0d | PROCUREMENT<$50K 60 NO ESCALATION; PROCUREMENT>$50K 69 NO ESCALATION | 79,980 | HOGAN J | 1 | 1 | JOHN H | 08-050 | 09-017 | 09-042 |  | 10-027 | 10-064 | 11-003 | 11-051 | APP | 3113C |  |  |  |  |  |  |  |  |  |
| 131137015 |  | Vend Fab - Cold Valves 13-16 | 146d | 2009-09-25 | 2010-04-30 | 9-100M FS-4d | 144d | 0d | PROCUREMENT<$50K 60 NO ESCALATION; PROCUREMENT>$50K 69 NO ESCALATION | 79,980 | HOGAN J | 1 | 1 | JOHN H | 08-050 | 09-017 | 09-042 |  | 10-027 | 10-064 | 11-003 | 11-051 |  |  |  |  |  |  |  |  |  |  |  |
| 131137016 |  | Vend Fab - Cold Valves 17-20 | 146d | 2009-09-25 | 2010-04-30 | 9-100M FS-4d | 144d | 0d | PROCUREMENT>$50K 69 NO ESCALATION; PROCUREMENT<$50K 60 NO ESCALATION | 79,980 | HOGAN J | 1 | 1 | JOHN H |  |  | 09-042 |  | 10-027 | 10-064 | 11-003 | 11-051 |  |  |  |  |  |  |  |  |  |  |  |
| 131137017 |  | Vend Fab - Cold Valves 21-22 | 166d | 2009-09-25 | 2010-05-28 | 9-100M FS-4d | 144d | 0d | PROCUREMENT<$50K 60 NO ESCALATION; PROCUREMENT>$50K 69 NO ESCALATION | 39,990 | HOGAN J | 1 | 1 | JOHN H |  |  | 09-042 |  | 10-027 | 10-064 | 11-003 | 11-051 |  |  |  |  |  |  |  |  |  |  |  |
| 131137010b |  | Proc Beam Pipes Labor FY10 | 97d | 2009-10-01 | 2010-02-26 | 131137010 | 176d | 4d | MECH DES [15.37 h]; MECH ENG [19.21 h] | 1,960.32 | HOGAN J | 1 | 1 | JOHN H |  |  |  | 10-001B | 10-027 | 10-064 | 11-003 | 11-051 |  |  |  |  |  |  |  |  |  |  |  |
| 131137011 |  | Vendor Fab Cold Valves - Oversight | 60d | 2009-10-01 | 2010-01-04 | 9-100M, 131137010b FS-101d | 172d | 28d | MECH DES [10 h]; MECH ENG [10 h]; SUPPLIES & MATERIALS | 5,231.35 | HOGAN J | 1 | 1 | JOHN H |  |  | 09-042 |  | 10-027 | 10-064 | 11-003 | 11-051 |  |  |  |  |  |  |  |  |  |  |  |
| 131137025 |  | Vendor Fab Burst Disc | 97d | 2009-10-01 | 2010-02-26 | 9-100M | 272d | 0d | MECH ENG [10 h]; SUPPLIES & MATERIALS; PROCUREMENT<$50K 60; MECH DES [10 h] | 14,021.63 | HOGAN J | 1 | 1 | JOHN H |  |  | 09-042 |  | 10-027 | 10-064 | 11-003 | 11-051 |  |  | 12-018F |  |  |  |  |  |  |  |  |
| 131137045 |  | Vendor Fab Warm Valves | 181d | 2009-12-04 | 2010-08-27 | 9-100M FS+44d | 165d | 0d | SUPPLIES & MATERIALS; PROCUREMENT<$50K 60; MECH DES [10 h]; MECH ENG [10 h] | 49,182.76 | HOGAN J | 1 | 1 | JOHN H |  |  | 09-042 |  | 10-027 | 10-064 | 11-003 | 11-051 |  |  | 12-018F |  |  |  |  |  |  |  |  |
| 131137034 |  | Vendor Fab Warm to Cold Beam Pipe - Oversight | 165d | 2010-01-05 | 2010-08-27 | 9-100M FS+60d | 165d | 0d | MECH DES [10 h]; SUPPLIES & MATERIALS; MECH ENG [10 h] | 5,231.35 | HOGAN J | 1 | 1 | JOHN H |  |  | 09-042 |  | 10-027 | 10-064 | 11-003 | 11-051 |  |  | 12-018F |  |  |  |  |  |  |  |  |
| 131137020 |  | Receive & Inspect Cold Valves | 74d | 2010-02-16 | 2010-05-28 | 131137017 FS-74d, 131137015 FS-54d, 131137011, 131137014 FS-32d, 131137016 FS-54d, 131137012 FS-9d, 131137013 FS-32d | 144d | 107d | MECH ENG [10 h]; MECH DES [8 h]; SUPPLIES & MATERIALS; MECH TECH [80 h] | 5,238.67 | HOGAN J | 1 | 1 | JOHN H |  |  | 09-042 |  | 10-027 | 10-064 | 11-003 | 11-051 |  |  |  |  |  |  |  |  |  |  |  |
| 131137030 |  | Receive & Inspect Burst Disc | 23d | 2010-03-01 | 2010-03-31 | 131137025 | 272d | 200d | MECH ENG [4 h]; MECH DES [3.2 h]; SUPPLIES & MATERIALS; MECH TECH [32 h] | 1,890.36 | HOGAN J | 1 | 1 | JOHN H |  |  | 09-042 |  | 10-027 | 10-064 | 11-003 | 11-051 |  |  | 12-018F |  |  |  |  |  |  |  |  |
| 131137050 |  | Receive & Inspect Warm Valves | 113d | 2010-03-24 | 2010-08-31 | 131137045 FS-111d | 165d | 93d | SUPPLIES & MATERIALS; MECH TECH [16 h]; MECH ENG [2 h]; MECH DES [1.6 h] | 1,750.97 | HOGAN J | 1 | 1 | JOHN H |  |  | 09-042 |  | 10-027 | 10-064 | 11-003 | 11-051 |  |  | 12-018F |  |  |  |  |  |  |  |  |
| 131137040 |  | Receive & Inspect Warm to Cold Beam Pipe | 105d | 2010-04-05 | 2010-08-31 | 131137035 FS-184d, 131137034 FS-103d | 165d | 93d | MECH TECH [32 h]; MECH ENG [4 h]; MECH DES [3.2 h]; SUPPLIES & MATERIALS | 2,036.87 | HOGAN J | 1 | 1 | JOHN H |  |  | 09-042 |  | 10-027 | 10-064 | 11-003 | 11-051 |  |  | 12-018F |  |  |  |  |  |  |  |  |
| 131137035 |  | Vendor Fab Warm to Cold Beam Pipe | 122d | 2010-07-01 | 2010-12-30 | 9-100M FS+184d | 165d | 0d | PROCUREMENT>$50K 69 NO ESCALATION FY11; PROCUREMENT<$50K 60 NO ESCALATION FY11 | 100,000 | HOGAN J | 1 | 1 | JOHN H |  |  | 09-042 |  | 10-027 | 10-064 | 11-003 | 11-051 |  |  | 12-018F |  |  |  |  |  |  |  |  |
| 131137055 |  | Re-Baseline Actuals Adjustment | 1d | 2013-08-30 | 2013-08-30 | 9-130M FS+227d | 20d |  | PROCUREMENT>$50K 69 NO ESCALATION | -43,720.49 | HOGAN J | 1 | 1 | JOHN H |  |  |  |  |  |  |  |  |  |  |  | 13-014 | ADJ |  |  |  |  |  |  |
|  | 8 | **1.3.1.1.3.8 TOP HATS** |  | 2009-05-13 | 2013-08-30 |  |  |  |  |  |  |  |  |  |  |  |  |  |  |  |  |  |  |  |  |  |  |  |  |  |  |  |  |
| 131138010 |  | Proc Top Hats Air Side FPC Components | 60d | 2009-05-13 | 2009-08-06 | 9-090M FS+150d | 135d | 0d | MECH ENG [20 h]; MECH DES [16 h] | 1,977.64 | HOGAN J | 1 | 1 | JOHN H | 08-050 | 09-017 |  |  | 10-027 | 10-064 | 11-003 | 11-051 |  |  | 12-018F |  |  |  |  |  |  |  |  |
| 131138015 |  | Vend Fab - Warm Windows Labor FY09 | 38d | 2009-08-07 | 2009-09-30 | 131138010 | 287d | 0d | SUPPLIES & MATERIALS; MECH TECH [10.13 h]; MECH ENG [25.33 h]; MECH DES [15.2 h]; TRAVEL; ELEC ENG [5.07 h] | 5,783.06 | HOGAN J | 1 | 1 | JOHN H | 08-050 | 09-017 |  | 10-001B | 10-027 | 10-064 | 11-003 | 11-051 | APP | 3113D | 12-018F |  |  |  |  |  |  |  |  |
| 131138015c |  | Vend Fab - Warm Windows Lot 1 and 2 | 200d | 2009-08-07 | 2010-05-28 | 131138010 | 223d | 0d | PROCUREMENT<$50K 60 NO ESCALATION FY10; PROCUREMENT>$50K 69 NO ESCALATION FY10 | 107,824.04 | HOGAN J | 1 | 1 | JOHN H |  |  |  | 10-001B | 10-027 | 10-064 | 11-003 | 11-051 | APP | 3113D | 12-018F |  |  | 10-012 |  |  |  |  |  |
| 131138015b |  | Vend Fab - Warm Windows Labor FY10 Initial | 41d | 2009-10-01 | 2009-11-30 | 131138015 | 287d | 0d | SUPPLIES & MATERIALS; MECH TECH [10.93 h]; MECH ENG [27.33 h]; MECH DES [16.4 h]; ELEC ENG [5.47 h]; TRAVEL | 6,438.96 | HOGAN J | 1 | 1 | JOHN H |  |  |  | 10-001B | 10-027 | 10-064 | 11-003 | 11-051 | APP | 3113D | 12-018F |  |  | 10-012 |  |  |  |  |  |
| 131138025 |  | Vendor Fab Vacuum Components Labor Initial | 39d | 2009-10-05 | 2009-11-30 | 131138010 FS+40d | 144d | 0d | MECH ENG [26 h]; MECH TECH [26 h]; MECH DES [10.4 h]; TRAVEL; SUPPLIES & MATERIALS; ELEC ENG [13.2 h] | 8,784.97 | HOGAN J | 1 | 1 | JOHN H | 08-050 | 09-017 |  |  | 10-027 | 10-064 | 11-003 | 11-051 | APP | 3113D | 12-018F |  |  | 10-012 |  |  |  |  |  |
| 131138025a5 |  | Vendor Fab Vacuum Components Labor Procurement | 225d | 2009-10-05 | 2010-08-31 | 131138010 FS+40d | 144d | 0d | PROCUREMENT>$50K 69 | 786,919.05 | HOGAN J | 1 | 1 | JOHN H |  |  |  |  | 10-027 | 10-064 | 11-003 | 11-051 | APP | 3113D | 12-018F |  |  | 10-012 |  |  |  |  |  |
| 131138035 |  | Support for Diagnostic Components Procurement | 60d | 2009-10-05 | 2010-01-06 | 131138010 FS+40d | 223d | 145d | MECH DES [40 h]; MECH TECH [20 h]; SUPPLIES & MATERIALS; ELEC ENG [20 h]; TRAVEL; MECH ENG [40 h]; ELEC TECH [20 h] | 14,574.91 | HOGAN J | 1 | 1 | JOHN H | 08-050 | 09-017 |  |  | 10-027 | 10-064 | 11-003 | 11-051 | APP | 3113D |  |  |  |  | 10-012A |  |  |  |  |
| 131138015ba |  | Vend Fab - Warm Windows Labor FY10 Final | 207d | 2009-12-01 | 2010-09-30 | 131138015b | 287d | 64d | ELEC ENG [9.46 h]; TRAVEL; SUPPLIES & MATERIALS; MECH TECH [18.94 h]; MECH ENG [47.34 h]; MECH DES [28.4 h] | 11,150.39 | HOGAN J | 1 | 1 | JOHN H |  |  |  |  | 10-027 | 10-064 | 11-003 | 11-051 | APP | 3113D | 12-018F |  |  | 10-012 |  |  |  |  |  |
| 131138025a |  | Vendor Fab Vacuum Components Labor Final | 186d | 2009-12-01 | 2010-08-31 | 131138025 | 144d | 0d | SUPPLIES & MATERIALS; ELEC ENG [7.2 h]; MECH ENG [14 h]; MECH TECH [14 h]; MECH DES [5.6 h]; TRAVEL | 4,736.48 | HOGAN J | 1 | 1 | JOHN H |  |  |  |  | 10-027 | 10-064 | 11-003 | 11-051 | APP | 3113D | 12-018F |  |  | 10-012 |  |  |  |  |  |
| 131138037 |  | Diagnostic Components Procurement Lots 1 thru 4 | 168d | 2010-01-04 | 2010-08-31 | 131138010 FS+40d, 9-100M FS+59d | 78d | 0d | PROCUREMENT>$50K 69 | 393,459.52 | HOGAN J | 1 | 1 | JOHN H |  |  |  |  | 10-027 | 10-064 | 11-003 | 11-051 | APP | 3113D |  |  |  |  | 10-012A |  |  |  |  |
| 131138030 |  | Receive & Insp Vacuum Components | 166d | 2010-02-05 | 2010-09-30 | 131138025a5 FS-145d, 131138025a FS-145d | 144d | 72d | SUPPLIES & MATERIALS; ELEC TECH [40 h]; MECH TECH [120 h]; MECH DES [16 h]; MECH ENG [20 h] | 9,806.43 | HOGAN J | 1 | 1 | JOHN H | 08-050 | 09-017 |  |  | 10-027 | 10-064 | 11-003 | 11-051 |  |  | 12-018F |  |  | 10-012 |  |  |  |  |  |
| 131138020 |  | Receive & Insp Warm Windows Lot 1 | 22d | 2010-06-01 | 2010-06-30 | 131138015ba FS-150d, 131138015c | 223d | 0d | MECH ENG [20 h]; MECH TECH [30 h]; SUPPLIES & MATERIALS; ELEC TECH [10 h]; ELEC ENG [10 h]; MECH DES [10 h] | 4,373.5 | HOGAN J | 1 | 1 | JOHN H | 08-050 | 09-017 |  |  | 10-027 | 10-064 | 11-003 | 11-051 |  |  | 12-018F |  |  | 10-012 |  |  |  |  |  |
| 131138020a |  | Acceptance Warm Windows Phase 1 | 1d | 2010-06-30 | 2010-06-30 | 131138020 FS-1d | 317d | 0d | PROCUREMENT<$50K 60 | 43,129.62 | HOGAN J | 1 | 1 | JOHN H |  |  |  |  | 10-027 | 10-064 |  | 11-051 |  |  | 12-018F |  |  | 10-012 |  | 10-066 | 11-012 | 12-028F |  |
| 131138020b |  | Receive & Insp Warm Windows Lot 2 FY10 | 64d | 2010-07-01 | 2010-09-30 | 131138020, 131138015c, 131138020a | 317d | 0d | ELEC TECH [7.11 h]; ELEC ENG [7.11 h]; MECH DES [7.11 h]; MECH ENG [14.22 h]; MECH TECH [21.33 h]; SUPPLIES & MATERIALS | 3,109.59 | HOGAN J | 1 | 1 | JOHN H |  |  |  |  | 10-027 | 10-064 |  | 11-051 |  |  | 12-018F |  |  | 10-012 |  | 10-066 | 11-012 | 12-028F | 11-001 |
| 131138060LOE |  | SOTR Oversight FY10 | 64d | 2010-07-01 | 2010-09-30 | 9-100M FS+184d | 435d | 0d | MECH ENG [256 h] | 16,857.6 | HOGAN J | 1 | 1 | JOHN H |  |  |  |  | 10-027 | 10-064 |  | 11-051 |  |  | 12-018F |  |  | 10-012 |  | 10-066 |  | 12-028F |  |
| 131138015d |  | Vend Fab - Warm Windows Lot 3 and 4 | 248d | 2010-07-30 | 2011-07-29 | 9-100M FS+204d | 398d | 0d | PROCUREMENT>$50K 69 NO ESCALATION FY11; PROCUREMENT<$50K 60 NO ESCALATION FY11 | 172,119.34 | HOGAN J | 1 | 1 | JOHN H |  |  |  |  | 10-027 | 10-064 |  | 11-051 | APP | 3113D | 12-018F |  |  | 10-012 |  | 10-066 |  | 12-028F |  |
| 131138015f |  | Vend Fab - Warm Windows Coatings | 248d | 2010-07-30 | 2011-07-29 | 9-100M FS+204d | 398d | 0d | PROCUREMENT<$50K 60 NO ESCALATION FY11; PROCUREMENT>$50K 69 NO ESCALATION FY11 | 90,000 | HOGAN J | 1 | 1 | JOHN H |  |  |  |  | 10-027 | 10-064 |  | 11-051 | APP | 3113D | 12-018F |  |  | 10-012 |  | 10-066 |  | 12-028F |  |
| 131138040 |  | Receive & Insp Diagnostic Components Lot 1 | 21d | 2010-08-04 | 2010-09-01 | 131138010, 131138037 FS-20d, 131138035 | 78d | 0d | MECH ENG [20 h]; SUPPLIES & MATERIALS; ELEC ENG [20 h]; ELEC TECH [20 h]; MECH TECH [20 h]; MECH DES [20 h] | 8,232.66 | HOGAN J | 1 | 1 | JOHN H | 08-050 | 09-017 |  |  | 10-027 | 10-064 | 11-003 | 11-051 |  |  |  |  |  |  | 10-012A |  |  |  |  |
| 131138045 |  | Receive & Insp Diagnostic Components Lot 2 FY10 | 20d | 2010-09-02 | 2010-09-30 | 131138040 | 237d | 0d | ELEC TECH [16 h]; MECH TECH [16 h]; MECH DES [16 h]; MECH ENG [16 h]; SUPPLIES & MATERIALS; ELEC ENG [16 h] | 6,586.13 | HOGAN J | 1 | 1 | JOHN H | 08-050 | 09-017 |  |  | 10-027 | 10-064 | 11-003 | 11-051 |  |  | 12-018F |  |  |  | 10-012A |  | 11-012 | 12-028F | 11-001 |
| 131138020ba |  | Receive & Insp Warm Windows Lot 2 FY11 | 26d | 2010-10-01 | 2010-11-05 | 131138020b | 317d | 282d | ELEC TECH [2.89 h]; ELEC ENG [2.89 h]; MECH DES [2.89 h]; MECH ENG [5.78 h]; MECH TECH [8.67 h]; SUPPLIES & MATERIALS | 1,304.2 | HOGAN J | 1 | 1 | JOHN H |  |  |  |  | 10-027 | 10-064 |  | 11-051 |  |  | 12-018F |  |  | 10-012 |  | 10-066 | 11-012 | 12-028F | 11-001 |
| 131138045a |  | Receive & Insp Diagnostic Components Lot 2 FY11 | 5d | 2010-10-01 | 2010-10-07 | 131138045 | 237d | 0d | ELEC TECH [4 h]; MECH DES [4 h]; MECH ENG [4 h]; SUPPLIES & MATERIALS; ELEC ENG [4 h]; MECH TECH [4 h] | 1,699.01 | HOGAN J | 1 | 1 | JOHN H | 08-050 | 09-017 |  |  | 10-027 | 10-064 | 11-003 | 11-051 |  |  | 12-018F |  |  |  | 10-012A |  | 11-012 | 12-028F | 11-001 |
| 131138065LOE |  | SOTR Oversight FY11 | 221d | 2010-10-01 | 2011-08-23 | 131138060LOE | 435d | 294d | MECH ENG [920 h] | 62,514 | HOGAN J | 1 | 1 | JOHN H |  |  |  |  | 10-027 | 10-064 |  | 11-051 |  |  | 12-018F |  |  | 10-012 |  | 10-066 |  | 12-028F |  |
| 131138050 |  | Receive & Insp Diagnostic Components Lot 3 | 25d | 2010-10-08 | 2010-11-11 | 131138045a | 308d | 0d | MECH TECH [20 h]; MECH DES [20 h]; MECH ENG [20 h]; SUPPLIES & MATERIALS; ELEC ENG [20 h]; ELEC TECH [20 h] | 8,495.05 | HOGAN J | 1 | 1 | JOHN H | 08-050 | 09-017 |  |  | 10-027 | 10-064 |  | 11-051 |  |  | 12-018F |  |  |  | 10-012A |  |  |  |  |
| 131138020d |  | Receive & Insp Warm Windows Lot 3 | 90d | 2010-11-08 | 2011-03-25 | 131138015d FS-178d, 131138015f FS-178d | 398d | 236d | ELEC TECH [10 h]; ELEC ENG [10 h]; MECH DES [10 h]; MECH ENG [20 h]; MECH TECH [30 h]; SUPPLIES & MATERIALS | 4,512.86 | HOGAN J | 1 | 1 | JOHN H |  |  |  |  | 10-027 | 10-064 |  | 11-051 |  |  | 12-018F |  |  | 10-012 |  | 10-066 |  | 12-028F |  |
| 131138055 |  | Receive & Insp Diagnostic Components Lot 4 | 25d | 2010-11-12 | 2010-12-20 | 131138050 | 334d | 284d | MECH ENG [20 h]; SUPPLIES & MATERIALS; ELEC ENG [20 h]; ELEC TECH [20 h]; MECH TECH [20 h]; MECH DES [20 h] | 8,495.05 | HOGAN J | 1 | 1 | JOHN H | 08-050 | 09-017 |  |  | 10-027 | 10-064 |  | 11-051 |  |  | 12-018F |  |  |  | 10-012A |  |  |  |  |
| 131138020g |  | Receive & Insp Warm Windows Lot 4 | 90d | 2011-04-18 | 2011-08-23 | 131138015f FS-73d, 131138015d FS-73d | 405d | 259d | ELEC TECH [10 h]; ELEC ENG [10 h]; MECH DES [10 h]; MECH ENG [20 h]; MECH TECH [30 h]; SUPPLIES & MATERIALS | 4,512.86 | HOGAN J | 1 | 1 | JOHN H |  |  |  |  | 10-027 | 10-064 |  | 11-051 |  |  | 12-018F |  |  | 10-012 |  | 10-066 |  | 12-028F |  |
| 131138070 |  | Re-Baseline Actuals Adjustment | 1d | 2013-08-30 | 2013-08-30 | 9-130M FS+227d | 20d |  | PROCUREMENT>$50K 69 NO ESCALATION | 407,552.64 | HOGAN J | 1 | 1 | JOHN H |  |  |  |  |  |  |  |  |  |  |  | 13-014 | ADJ |  |  |  |  |  |  |

Notes:
- 131137020: Steps: Receive & Inspect Cold Valves 1-4; Receive & Inspect Cold Valves 5-8; Receive & Inspect Cold Valves 9-12; Receive & Inspect Cold Valves 13-16; Receive & Inspect Cold Valves 17-20; Receive & Inspect Cold Valves 21-22
- 131137050: Steps: Receive & Inspect Warm Valves 1-4; Receive & Inspect Warm Valves 5-8; Receive & Inspect Warm Valves 9-12; Receive & Inspect Warm Valves 13-16; Receive & Inspect Warm Valves 17-20; Receive & Inspect Warm Valves 21-22

| ID | WBS | Activity | Duration | Start | Finish | Predecessors | Total float | Free float | Resources | Cost | RESP - Responsibility | STRT%COMP for CM EVM | FNSH%COMP for CM EVM | CAM RESPONSIBLE | CR 08-050 | CR 09-017 | CR 10-027 | CR 10-064 | CR 11-003 | CR 11-051 | CR 12-018 | CR 13-014 | ReBaseline Actuals Adjustment | CR 11-001 | CR 09-032 | CR 09-032 Repair | CR 11-012 |
| --- | --- | --- | --- | --- | --- | --- | --- | --- | --- | --- | --- | --- | --- | --- | --- | --- | --- | --- | --- | --- | --- | --- | --- | --- | --- | --- | --- |
|  | 9 | **1.3.1.1.3.9 SUPPORTS** |  | 2009-10-01 | 2013-08-30 |  |  |  |  |  |  |  |  |  |  |  |  |  |  |  |  |  |  |  |  |  |  |
| 131139010 |  | Proc Supprts | 50d | 2009-10-01 | 2009-12-11 | 9-100M | 261d | 0d | MECH ENG [20 h]; MECH DES [16 h] | 2,040.84 | HOGAN J | 1 | 1 | JOHN H | 08-050 | 09-017 | 10-027 | 10-064 | 11-003 | 11-051 | 12-018F |  |  |  |  |  |  |
| 131139015 |  | Vend Fab - Supprts | 65d | 2009-12-14 | 2010-03-24 | 131139010 | 261d | 0d | MECH ENG [40 h]; PROCUREMENT<$50K 60; SUPPLIES & MATERIALS; MECH DES [40 h] | 64,876.79 | HOGAN J | 1 | 1 | JOHN H | 08-050 | 09-017 | 10-027 | 10-064 | 11-003 | 11-051 | 12-018F |  |  |  |  |  |  |
| 131139025 |  | Receive & Insp Supprts | 16d | 2010-03-25 | 2010-04-15 | 131139015, 131139020 FS-80d | 261d | 189d | SUPPLIES & MATERIALS; MECH TECH [40 h] | 2,218.99 | HOGAN J | 1 | 1 | JOHN H | 08-050 | 09-017 | 10-027 | 10-064 | 11-003 | 11-051 | 12-018F |  |  |  |  |  |  |
| 131139020 |  | Additional Support Baseplates | 5d | 2010-07-12 | 2010-07-16 | 131139010 FS+140d | 261d | 0d | PROCUREMENT>$50K 69 | 70,000 | HOGAN J | 1 | 1 | JOHN H | 08-050 | 09-017 | 10-027 | 10-064 | 11-003 | 11-051 | 12-018F |  |  |  |  |  |  |
| 131139030 |  | Re-Baseline Actuals Adjustment | 1d | 2013-08-30 | 2013-08-30 | 9-130M FS+227d | 20d |  | PROCUREMENT>$50K 69 NO ESCALATION | -12,504.76 | HOGAN J | 1 | 1 | JOHN H |  |  |  |  |  |  |  | 13-014 | ADJ |  |  |  |  |
|  | 4 | **1.3.1.1.4 INSTALLATION AND ASSEMBLY TOOLING PROCUREMENTS** |  | 2009-10-01 | 2013-08-30 |  |  |  |  |  |  |  |  |  |  |  |  |  |  |  |  |  |  |  |  |  |  |
| 13114010 |  | Vend Fab - Installtn & Assy Tooling | 120d | 2009-10-01 | 2010-03-31 | 9-100M, 1211020M15 | 212d | 0d | SUPPLIES & MATERIALS; PROCUREMENT<$50K 60 | 73,618.62 | HOGAN J | 1 | 1 | JOHN H | 08-050 |  | 10-027 | 10-064 | 11-003 | 11-051 | 12-018F |  |  |  |  |  |  |
| 13114015 |  | Receive & Insp Installtn & Assy Tooling | 20d | 2010-04-01 | 2010-04-28 | 13114010 | 212d | 140d | MECH DES [320 h]; MECH ENG [160 h]; SUPPLIES & MATERIALS | 27,210.38 | HOGAN J | 1 | 1 | JOHN H | 08-050 | 09-017 | 10-027 | 10-064 | 11-003 | 11-051 | 12-018F |  |  |  |  |  |  |
| 13114012 |  | Vend Fab - Installtn & Assy Tooling Phase 2 | 64d | 2010-07-01 | 2010-09-30 | 9-100M FS+184d | 79d | 0d | PROCUREMENT<$50K 60 | 300,000 | HOGAN J | 1 | 1 | JOHN H |  |  |  | 10-064 | 11-003 | 11-051 | 12-018F |  |  |  |  |  |  |
| 13114020 |  | Receive & Insp Installtn & Assy Tooling Phase 2 FY10 | 15d | 2010-09-10 | 2010-09-30 | 13114012 FS-15d | 79d | 0d | SUPPLIES & MATERIALS; MECH DES [750 h]; MECH ENG [330 h]; MECH TECH [450 h] | 85,693.5 | HOGAN J | 1 | 1 | JOHN H |  |  |  | 10-064 | 11-003 | 11-051 | 12-018F |  |  | 11-001 |  |  |  |
| 13114020a |  | Receive & Insp Installtn & Assy Tooling Phase 2 FY11 | 25d | 2010-10-01 | 2010-11-04 | 13114020 | 79d | 7d | MECH ENG [550 h]; MECH TECH [750 h]; SUPPLIES & MATERIALS; MECH DES [1250 h] | 147,373.13 | HOGAN J | 1 | 1 | JOHN H |  |  |  | 10-064 | 11-003 | 11-051 | 12-018F |  |  | 11-001 |  |  |  |
| 13114025 |  | Re-Baseline Actuals Adjustment | 1d | 2013-08-30 | 2013-08-30 | 9-130M FS+227d | 20d |  | PROCUREMENT>$50K 69 NO ESCALATION | 229,301.21 | HOGAN J | 1 | 1 | JOHN H |  |  |  |  |  |  |  | 13-014 | ADJ |  |  |  |  |
|  | 4 | **1.3.1.1.4.4 INSTALLATION AND ASSEMBLY TOOLING** |  |  |  |  |  |  |  |  |  |  |  |  |  |  |  |  |  |  |  |  |  |  |  |  |  |
|  | 5 | **1.3.1.1.5 CRYOMODULE TEST INSTRUMENTATION & INTERLOCKS PROCUREMENT** |  | 2009-10-01 | 2010-02-02 |  |  |  |  |  |  |  |  |  |  |  |  |  |  |  |  |  |  |  |  |  |  |
| 13115010 |  | Vend Fab - Instrmenttn & Interlocks | 60d | 2009-10-01 | 2010-01-04 | 9-100M | 312d | 0d |  |  | HOGAN J | 1 | 1 | JOHN H | 08-050 | 09-017 | 10-027 | 10-064 | 11-003 | 11-051 | 12-018F |  |  |  |  |  |  |
| 13115015 |  | Receive & Insp Instrmenttn & Interlocks | 20d | 2010-01-05 | 2010-02-02 | 13115010 | 312d | 240d |  |  | HOGAN J | 1 | 1 | JOHN H | 08-050 | 09-017 | 10-027 | 10-064 | 11-003 | 11-051 | 12-018F |  |  |  |  |  |  |
|  | 5 | **1.3.1.1.5.5 INSTRUMENTATION & INTERLOCKS** |  |  |  |  |  |  |  |  |  |  |  |  |  |  |  |  |  |  |  |  |  |  |  |  |  |
|  | 2 | **1.3.1.2 CAVITY STRING ASSEMBLY** |  | 2010-08-05 | 2013-08-30 |  |  |  |  |  |  |  |  |  |  |  |  |  |  |  |  |  |  |  |  |  |  |
| 1312000 |  | Re-Baseline Actuals Adjustment | 1d | 2013-08-30 | 2013-08-30 | 9-130M FS+227d | 20d |  | PROCUREMENT>$50K 69 NO ESCALATION | -212,822.09 | HOGAN J | 1 | 1 | JOHN H |  |  |  |  |  |  |  | 13-014 | ADJ |  |  |  |  |
|  | 1 | **1.3.1.2.1 CAVITY PREPARATION** |  | 2010-08-05 | 2011-11-16 |  |  |  |  |  |  |  |  |  |  |  |  |  |  |  |  |  |  |  |  |  |  |
|  | 01 | **1.3.1.2.1.01 CAVITY STRING #1 PREPERATION** |  | 2010-08-05 | 2010-11-05 |  |  |  |  |  |  |  |  |  |  |  |  |  |  |  |  |  |  |  |  |  |  |
| 1312101005 |  | Cavity String #1 Helium Vessel Welding | 15d | 2010-08-05 | 2010-08-25 | 131114070, 1311122010, 131114075, 1311122005 | 57d | 20d | ELEC TECH [8 h]; MECH DES [4 h]; MECH ENG [8 h]; MECH TECH [120 h]; SUPPLIES & MATERIALS | 7,048.16 | HOGAN J | 1 | 1 | JOHN H | 08-050 | 09-017 | 10-027 | 10-064 | 11-003 | 11-051 |  |  |  |  | 09-032 | 09-032 | 11-012 |
| 1312101030 |  | Cavity #1 VTA Run | 5d | 2010-09-10 | 2010-09-16 | 1317000, 1312101005 FS-10d | 37d | 0d | SCIENTIST [8 h]; SR STAFF [8 h]; COMP SCIENT [8 h]; ELEC ENG [8 h]; ELEC TECH [8 h]; MECH DES [8 h]; MECH ENG [8 h]; MECH TECH [8 h] | 3,956.8 | HOGAN J | 1 | 1 | JOHN H | 08-050 | 09-017 | 10-027 | 10-064 | 11-003 | 11-051 |  |  |  |  | 09-032 | 09-032 | 11-012 |
| 1312101035 |  | Cavity #2 VTA Run | 5d | 2010-09-15 | 2010-09-21 | 1312101030 FS-2d | 37d | 0d | SCIENTIST [8 h]; SR STAFF [8 h]; COMP SCIENT [8 h]; ELEC ENG [8 h]; MECH ENG [8 h]; ELEC TECH [8 h]; MECH DES [8 h]; MECH TECH [8 h] | 3,956.8 | HOGAN J | 1 | 1 | JOHN H | 08-050 | 09-017 | 10-027 | 10-064 | 11-003 | 11-051 |  |  |  |  | 09-032 | 09-032 | 11-012 |
| 1312101040 |  | Cavity #3 VTA Run | 5d | 2010-09-20 | 2010-09-24 | 1312101035 FS-2d | 37d | 0d | COMP SCIENT [8 h]; ELEC ENG [8 h]; ELEC TECH [8 h]; MECH DES [8 h]; MECH ENG [8 h]; MECH TECH [8 h]; SCIENTIST [8 h]; SR STAFF [8 h] | 3,956.8 | HOGAN J | 1 | 1 | JOHN H | 08-050 | 09-017 | 10-027 | 10-064 | 11-003 | 11-051 |  |  |  |  | 09-032 | 09-032 | 11-012 |
| 1312101045 |  | Cavity #4 VTA Run | 5d | 2010-09-23 | 2010-09-29 | 1312101040 FS-2d | 37d | 0d | MECH DES [8 h]; MECH ENG [8 h]; MECH TECH [8 h]; SCIENTIST [8 h]; SR STAFF [8 h]; COMP SCIENT [8 h]; ELEC ENG [8 h]; ELEC TECH [8 h] | 3,956.8 | HOGAN J | 1 | 1 | JOHN H | 08-050 | 09-017 | 10-027 | 10-064 | 11-003 | 11-051 |  |  |  |  | 09-032 | 09-032 | 11-012 |
| 1312101050 |  | Cavity #5 VTA Run FY10 | 3d | 2010-09-28 | 2010-09-30 | 1312101045 FS-2d | 37d | 0d | MECH DES [4.8 h]; MECH ENG [4.8 h]; MECH TECH [4.8 h]; SCIENTIST [4.8 h]; SR STAFF [4.8 h]; COMP SCIENT [4.8 h]; ELEC ENG [4.8 h]; ELEC TECH [4.8 h] | 2,374.09 | HOGAN J | 1 | 1 | JOHN H | 08-050 | 09-017 | 10-027 | 10-064 | 11-003 | 11-051 |  |  |  | 11-001 | 09-032 | 09-032 | 11-012 |
| 1312101050a |  | Cavity #5 VTA Run FY11 | 2d | 2010-10-01 | 2010-10-04 | 1312101050 | 37d | 0d | ELEC TECH [3.2 h]; MECH DES [3.2 h]; MECH ENG [3.2 h]; MECH TECH [3.2 h]; SCIENTIST [3.2 h]; SR STAFF [3.2 h]; COMP SCIENT [3.2 h]; ELEC ENG [3.2 h] | 1,633.22 | HOGAN J | 1 | 1 | JOHN H | 08-050 | 09-017 | 10-027 | 10-064 | 11-003 | 11-051 |  |  |  | 11-001 | 09-032 | 09-032 | 11-012 |
| 1312101055 |  | Cavity #6 VTA Run | 5d | 2010-10-01 | 2010-10-07 | 1312101050a FS-2d | 37d | 0d | ELEC TECH [8 h]; MECH DES [8 h]; MECH ENG [8 h]; MECH TECH [8 h]; SCIENTIST [8 h]; SR STAFF [8 h]; COMP SCIENT [8 h]; ELEC ENG [8 h] | 4,083.04 | HOGAN J | 1 | 1 | JOHN H | 08-050 | 09-017 | 10-027 | 10-064 | 11-003 | 11-051 |  |  |  |  | 09-032 | 09-032 | 11-012 |
| 1312101060 |  | Cavity #7 VTA Run | 5d | 2010-10-06 | 2010-10-12 | 1312101055 FS-2d | 37d | 0d | SCIENTIST [8 h]; SR STAFF [8 h]; COMP SCIENT [8 h]; ELEC ENG [8 h]; ELEC TECH [8 h]; MECH DES [8 h]; MECH ENG [8 h]; MECH TECH [8 h] | 4,083.04 | HOGAN J | 1 | 1 | JOHN H | 08-050 | 09-017 | 10-027 | 10-064 | 11-003 | 11-051 |  |  |  |  | 09-032 | 09-032 | 11-012 |
| 1312101065 |  | Cavity #8 VTA Run | 5d | 2010-10-11 | 2010-10-15 | 1312101060 FS-2d | 37d | 0d | MECH TECH [8 h]; SCIENTIST [8 h]; SR STAFF [8 h]; COMP SCIENT [8 h]; ELEC ENG [8 h]; ELEC TECH [8 h]; MECH DES [8 h]; MECH ENG [8 h] | 4,083.04 | HOGAN J | 1 | 1 | JOHN H | 08-050 | 09-017 | 10-027 | 10-064 | 11-003 | 11-051 |  |  |  |  | 09-032 | 09-032 | 11-012 |
| 1312101002 |  | Cavity String #1 Cavity Processing | 5d | 2010-11-01 | 2010-11-05 | 1311122005, 1311122010 FS+61d | 101d | 0d | MECH ENG [12.4 h]; MECH TECH [178 h]; SUPPLIES & MATERIALS | 17,589.04 | HOGAN J | 1 | 1 | JOHN H |  |  |  |  | 11-003 | 11-051 | 12-018F |  |  |  |  |  | 11-012 |

| ID | WBS | Activity | Duration | Start | Finish | Predecessors | Total float | Free float | Resources | Cost | RESP - Responsibility | STRT%COMP for CM EVM | FNSH%COMP for CM EVM | CAM RESPONSIBLE | CR 08-050 | CR 09-017 | CR 09-032 | CR 09-032 Repair | CR 10-023 | CR 10-027 | CR 10-064 | CR 11-003 | CR 11-012 | CR 11-051 | CR 12-018 |
| --- | --- | --- | --- | --- | --- | --- | --- | --- | --- | --- | --- | --- | --- | --- | --- | --- | --- | --- | --- | --- | --- | --- | --- | --- | --- |
|  | 02 | **1.3.1.2.1.02 CAVITY STRING #2 PREPARATION** |  | 2010-10-08 | 2010-11-19 |  |  |  |  |  |  |  |  |  |  |  |  |  |  |  |  |  |  |  |  |
| 1312102005 |  | Cavity String #2 Helium Vessel Welding | 15d | 2010-10-08 | 2010-10-28 | 1311122020, 1311122015, 131114080, 1312101005 | 37d | 0d | MECH ENG [8 h]; SUPPLIES & MATERIALS; MECH TECH [120 h]; ELEC TECH [8 h]; MECH DES [4 h] | 7,272.78 | HOGAN J | 1 | 1 | JOHN H | 08-050 | 09-017 | 09-032 | 09-032 | 10-023 | 10-027 | 10-064 | 11-003 | 11-012 | 11-051 |  |
| 1312102030 |  | Cavity #9 VTA Run | 5d | 2010-10-15 | 2010-10-21 | 1312102005 FS-10d, 1312101065 FS-2d | 37d | 0d | SCIENTIST [8 h]; ELEC TECH [8 h]; MECH DES [8 h]; MECH ENG [8 h]; MECH TECH [8 h]; SR STAFF [8 h]; COMP SCIENT [8 h]; ELEC ENG [8 h] | 4,083.04 | HOGAN J | 1 | 1 | JOHN H | 08-050 | 09-017 | 09-032 | 09-032 | 10-023 | 10-027 | 10-064 | 11-003 | 11-012 | 11-051 |  |
| 1312102035 |  | Cavity #10 VTA Run | 5d | 2010-10-20 | 2010-10-26 | 1312102030 FS-2d | 37d | 0d | MECH ENG [8 h]; MECH TECH [8 h]; SCIENTIST [8 h]; SR STAFF [8 h]; COMP SCIENT [8 h]; ELEC ENG [8 h]; ELEC TECH [8 h]; MECH DES [8 h] | 4,083.04 | HOGAN J | 1 | 1 | JOHN H | 08-050 | 09-017 | 09-032 | 09-032 | 10-023 | 10-027 | 10-064 | 11-003 | 11-012 | 11-051 |  |
| 1312102040 |  | Cavity #11 VTA Run | 5d | 2010-10-25 | 2010-10-29 | 1312102035 FS-2d | 37d | 0d | ELEC ENG [8 h]; ELEC TECH [8 h]; MECH DES [8 h]; MECH ENG [8 h]; MECH TECH [8 h]; SCIENTIST [8 h]; SR STAFF [8 h]; COMP SCIENT [8 h] | 4,083.04 | HOGAN J | 1 | 1 | JOHN H | 08-050 | 09-017 | 09-032 | 09-032 | 10-023 | 10-027 | 10-064 | 11-003 | 11-012 | 11-051 |  |
| 1312102045 |  | Cavity #12 VTA Run | 5d | 2010-10-28 | 2010-11-03 | 1312102040 FS-2d | 37d | 0d | SR STAFF [8 h]; COMP SCIENT [8 h]; ELEC ENG [8 h]; ELEC TECH [8 h]; MECH DES [8 h]; MECH ENG [8 h]; MECH TECH [8 h]; SCIENTIST [8 h] | 4,083.04 | HOGAN J | 1 | 1 | JOHN H | 08-050 | 09-017 | 09-032 | 09-032 | 10-023 | 10-027 | 10-064 | 11-003 | 11-012 | 11-051 |  |
| 1312102050 |  | Cavity #13 VTA Run | 5d | 2010-11-02 | 2010-11-08 | 1312102045 FS-2d | 37d | 0d | MECH DES [8 h]; MECH ENG [8 h]; MECH TECH [8 h]; SCIENTIST [8 h]; SR STAFF [8 h]; COMP SCIENT [8 h]; ELEC ENG [8 h]; ELEC TECH [8 h] | 4,083.04 | HOGAN J | 1 | 1 | JOHN H | 08-050 | 09-017 | 09-032 | 09-032 | 10-023 | 10-027 | 10-064 | 11-003 | 11-012 | 11-051 |  |
| 1312102055 |  | Cavity #14 VTA Run | 5d | 2010-11-05 | 2010-11-11 | 1312102050 FS-2d | 37d | 0d | MECH ENG [8 h]; MECH TECH [8 h]; SCIENTIST [8 h]; SR STAFF [8 h]; COMP SCIENT [8 h]; ELEC ENG [8 h]; ELEC TECH [8 h]; MECH DES [8 h] | 4,083.04 | HOGAN J | 1 | 1 | JOHN H | 08-050 | 09-017 | 09-032 | 09-032 | 10-023 | 10-027 | 10-064 | 11-003 | 11-012 | 11-051 |  |
| 1312102002 |  | Cavity String #2 Cavity Processing | 5d | 2010-11-08 | 2010-11-12 | 1311122020, 1312101002, 1311122015 | 101d | 0d | MECH ENG [12.4 h]; MECH TECH [178 h]; SUPPLIES & MATERIALS | 17,589.04 | HOGAN J | 1 | 1 | JOHN H |  |  |  |  |  |  |  | 11-003 | 11-012 | 11-051 | 12-018F |
| 1312102060 |  | Cavity #15 VTA Run | 5d | 2010-11-10 | 2010-11-16 | 1312102055 FS-2d | 37d | 0d | MECH ENG [8 h]; MECH TECH [8 h]; SCIENTIST [8 h]; SR STAFF [8 h]; COMP SCIENT [8 h]; ELEC ENG [8 h]; ELEC TECH [8 h]; MECH DES [8 h] | 4,083.04 | HOGAN J | 1 | 1 | JOHN H | 08-050 | 09-017 | 09-032 | 09-032 | 10-023 | 10-027 | 10-064 | 11-003 | 11-012 | 11-051 |  |
| 1312102065 |  | Cavity #16 VTA Run | 5d | 2010-11-15 | 2010-11-19 | 1312102060 FS-2d | 37d | 0d | MECH DES [8 h]; MECH ENG [8 h]; MECH TECH [8 h]; SCIENTIST [8 h]; SR STAFF [8 h]; COMP SCIENT [8 h]; ELEC ENG [8 h]; ELEC TECH [8 h] | 4,083.04 | HOGAN J | 1 | 1 | JOHN H | 08-050 | 09-017 | 09-032 | 09-032 | 10-023 | 10-027 | 10-064 | 11-003 | 11-012 | 11-051 |  |
|  | 03 | **1.3.1.2.1.03 CAVITY STRING #3 PREPARATION** |  | 2010-11-15 | 2011-02-01 |  |  |  |  |  |  |  |  |  |  |  |  |  |  |  |  |  |  |  |  |
| 1312103005 |  | Cavity String #3 Cavity Process & He Vs Weld | 16d | 2010-11-15 | 2010-12-08 | 1311122022, 1312102002, 1312102005, 1311122025, 131114085 | 101d | 0d | ELEC TECH [8 h]; MECH DES [4 h]; MECH ENG [20.4 h]; MECH TECH [298 h]; SUPPLIES & MATERIALS | 24,861.92 | HOGAN J | 1 | 1 | JOHN H | 08-050 | 09-017 | 09-032 | 09-032 | 10-023 | 10-027 | 10-064 | 11-003 | 11-012 | 11-051 | 12-018F |
| 1312103030 |  | Cavity #17 VTA Run | 5d | 2010-11-23 | 2010-12-01 | 1312103005 FS-10d, 1312102065 FS-2d | 101d | 0d | SR STAFF [8 h]; COMP SCIENT [8 h]; ELEC ENG [8 h]; ELEC TECH [8 h]; MECH DES [8 h]; MECH ENG [8 h]; MECH TECH [8 h]; SCIENTIST [8 h] | 4,083.04 | HOGAN J | 1 | 1 | JOHN H | 08-050 | 09-017 | 09-032 | 09-032 | 10-023 | 10-027 | 10-064 | 11-003 | 11-012 | 11-051 | 12-018F |
| 1312103035 |  | Cavity #18 VTA Run | 5d | 2010-11-30 | 2010-12-06 | 1312103030 FS-2d | 101d | 0d | MECH DES [8 h]; MECH TECH [8 h]; MECH ENG [8 h]; SR STAFF [8 h]; SCIENTIST [8 h]; COMP SCIENT [8 h]; ELEC ENG [8 h]; ELEC TECH [8 h] | 4,083.04 | HOGAN J | 1 | 1 | JOHN H | 08-050 | 09-017 | 09-032 | 09-032 | 10-023 | 10-027 | 10-064 | 11-003 | 11-012 | 11-051 | 12-018F |
| 1312103040 |  | Cavity #19 VTA Run | 5d | 2010-12-03 | 2010-12-09 | 1312103035 FS-2d | 101d | 0d | SR STAFF [8 h]; COMP SCIENT [8 h]; ELEC ENG [8 h]; ELEC TECH [8 h]; MECH DES [8 h]; MECH ENG [8 h]; MECH TECH [8 h]; SCIENTIST [8 h] | 4,083.04 | HOGAN J | 1 | 1 | JOHN H | 08-050 | 09-017 | 09-032 | 09-032 | 10-023 | 10-027 | 10-064 | 11-003 | 11-012 | 11-051 | 12-018F |
| 1312103045 |  | Cavity #20 VTA Run | 5d | 2010-12-08 | 2010-12-14 | 1312103040 FS-2d | 101d | 0d | SCIENTIST [8 h]; SR STAFF [8 h]; COMP SCIENT [8 h]; ELEC ENG [8 h]; ELEC TECH [8 h]; MECH DES [8 h]; MECH TECH [8 h]; MECH ENG [8 h] | 4,083.04 | HOGAN J | 1 | 1 | JOHN H | 08-050 | 09-017 | 09-032 | 09-032 | 10-023 | 10-027 | 10-064 | 11-003 | 11-012 | 11-051 | 12-018F |
| 1312103050 |  | Cavity #21 VTA Run | 5d | 2010-12-13 | 2010-12-17 | 1312103045 FS-2d | 101d | 2d | MECH DES [8 h]; MECH ENG [8 h]; MECH TECH [8 h]; SCIENTIST [8 h]; SR STAFF [8 h]; COMP SCIENT [8 h]; ELEC ENG [8 h]; ELEC TECH [8 h] | 4,083.04 | HOGAN J | 1 | 1 | JOHN H | 08-050 | 09-017 | 09-032 | 09-032 | 10-023 | 10-027 | 10-064 | 11-003 | 11-012 | 11-051 | 12-018F |
| 1312103055 |  | Cavity #22 VTA Run | 5d | 2011-01-18 | 2011-01-24 | 1312103050 FS-2d, 1317005 | 99d | 0d | MECH TECH [8 h]; SCIENTIST [8 h]; SR STAFF [8 h]; COMP SCIENT [8 h]; ELEC ENG [8 h]; ELEC TECH [8 h]; MECH DES [8 h]; MECH ENG [8 h] | 4,083.04 | HOGAN J | 1 | 1 | JOHN H | 08-050 | 09-017 | 09-032 | 09-032 | 10-023 | 10-027 | 10-064 | 11-003 | 11-012 | 11-051 | 12-018F |
| 1312103060 |  | Cavity #23 VTA Run | 5d | 2011-01-21 | 2011-01-27 | 1312103055 FS-2d | 99d | 0d | MECH DES [8 h]; MECH ENG [8 h]; SCIENTIST [8 h]; SR STAFF [8 h]; COMP SCIENT [8 h]; ELEC ENG [8 h]; MECH TECH [8 h]; ELEC TECH [8 h] | 4,083.04 | HOGAN J | 1 | 1 | JOHN H | 08-050 | 09-017 | 09-032 | 09-032 | 10-023 | 10-027 | 10-064 | 11-003 | 11-012 | 11-051 | 12-018F |
| 1312103065 |  | Cavity #24 VTA Run | 5d | 2011-01-26 | 2011-02-01 | 1312103060 FS-2d | 99d | 0d | ELEC ENG [8 h]; ELEC TECH [8 h]; MECH DES [8 h]; MECH ENG [8 h]; MECH TECH [8 h]; SCIENTIST [8 h]; SR STAFF [8 h]; COMP SCIENT [8 h] | 4,083.04 | HOGAN J | 1 | 1 | JOHN H | 08-050 | 09-017 | 09-032 | 09-032 | 10-023 | 10-027 | 10-064 | 11-003 | 11-012 | 11-051 | 12-018F |
|  | 04 | **1.3.1.2.1.04 CAVITY STRING #4 PREPARATION** |  | 2010-12-09 | 2011-03-08 |  |  |  |  |  |  |  |  |  |  |  |  |  |  |  |  |  |  |  |  |
| 1312104005 |  | Cavity String #4 Cavity Process & He Vs Weld | 16d | 2010-12-09 | 2011-01-07 | 1311122030, 131114090, 1312103005, 1311122027 | 123d | 24d | MECH ENG [20.4 h]; MECH TECH [298 h]; SUPPLIES & MATERIALS; ELEC TECH [8 h]; MECH DES [4 h] | 24,861.92 | HOGAN J | 1 | 1 | JOHN H | 08-050 | 09-017 | 09-032 | 09-032 | 10-023 | 10-027 | 10-064 | 11-003 | 11-012 | 11-051 | 12-018F |
| 1312104030 |  | Cavity#25 VTA Run | 5d | 2011-01-31 | 2011-02-04 | 1312103065 FS-2d, 1312104005 FS-10d | 99d | 0d | ELEC TECH [8 h]; MECH DES [8 h]; MECH ENG [8 h]; MECH TECH [8 h]; SR STAFF [8 h]; SCIENTIST [8 h]; COMP SCIENT [8 h]; ELEC ENG [8 h] | 4,083.04 | HOGAN J | 1 | 1 | JOHN H | 08-050 | 09-017 | 09-032 | 09-032 | 10-023 | 10-027 | 10-064 | 11-003 | 11-012 | 11-051 | 12-018F |
| 1312104035 |  | Cavity#26 VTA Run | 5d | 2011-02-03 | 2011-02-09 | 1312104030 FS-2d | 99d | 0d | COMP SCIENT [8 h]; MECH TECH [8 h]; ELEC ENG [8 h]; MECH DES [8 h]; MECH ENG [8 h]; SR STAFF [8 h]; SCIENTIST [8 h]; ELEC TECH [8 h] | 4,083.04 | HOGAN J | 1 | 1 | JOHN H | 08-050 | 09-017 | 09-032 | 09-032 | 10-023 | 10-027 | 10-064 | 11-003 | 11-012 | 11-051 | 12-018F |
| 1312104040 |  | Cavity#27 VTA Run | 5d | 2011-02-08 | 2011-02-14 | 1312104035 FS-2d | 99d | 0d | SR STAFF [8 h]; SCIENTIST [8 h]; ELEC ENG [8 h]; ELEC TECH [8 h]; MECH DES [8 h]; MECH ENG [8 h]; MECH TECH [8 h]; COMP SCIENT [8 h] | 4,083.04 | HOGAN J | 1 | 1 | JOHN H | 08-050 | 09-017 | 09-032 | 09-032 | 10-023 | 10-027 | 10-064 | 11-003 | 11-012 | 11-051 | 12-018F |
| 1312104045 |  | Cavity#28 VTA Run | 5d | 2011-02-11 | 2011-02-17 | 1312104040 FS-2d | 99d | 0d | SCIENTIST [8 h]; COMP SCIENT [8 h]; ELEC ENG [8 h]; ELEC TECH [8 h]; MECH DES [8 h]; MECH ENG [8 h]; MECH TECH [8 h]; SR STAFF [8 h] | 4,083.04 | HOGAN J | 1 | 1 | JOHN H | 08-050 | 09-017 | 09-032 | 09-032 | 10-023 | 10-027 | 10-064 | 11-003 | 11-012 | 11-051 | 12-018F |
| 1312104050 |  | Cavity#29 VTA Run | 5d | 2011-02-16 | 2011-02-23 | 1312104045 FS-2d | 99d | 0d | SCIENTIST [8 h]; SR STAFF [8 h]; COMP SCIENT [8 h]; ELEC ENG [8 h]; ELEC TECH [8 h]; MECH DES [8 h]; MECH ENG [8 h]; MECH TECH [8 h] | 4,083.04 | HOGAN J | 1 | 1 | JOHN H | 08-050 | 09-017 | 09-032 | 09-032 | 10-023 | 10-027 | 10-064 | 11-003 | 11-012 | 11-051 | 12-018F |
| 1312104055 |  | Cavity#30 VTA Run | 5d | 2011-02-22 | 2011-02-28 | 1312104050 FS-2d | 99d | 0d | ELEC ENG [8 h]; ELEC TECH [8 h]; MECH DES [8 h]; MECH ENG [8 h]; MECH TECH [8 h]; SR STAFF [8 h]; SCIENTIST [8 h]; COMP SCIENT [8 h] | 4,083.04 | HOGAN J | 1 | 1 | JOHN H | 08-050 | 09-017 | 09-032 | 09-032 | 10-023 | 10-027 | 10-064 | 11-003 | 11-012 | 11-051 | 12-018F |
| 1312104060 |  | Cavity#31 VTA Run | 5d | 2011-02-25 | 2011-03-03 | 1312104055 FS-2d | 99d | 0d | COMP SCIENT [8 h]; ELEC ENG [8 h]; ELEC TECH [8 h]; MECH DES [8 h]; MECH ENG [8 h]; MECH TECH [8 h]; SR STAFF [8 h]; SCIENTIST [8 h] | 4,083.04 | HOGAN J | 1 | 1 | JOHN H | 08-050 | 09-017 | 09-032 | 09-032 | 10-023 | 10-027 | 10-064 | 11-003 | 11-012 | 11-051 | 12-018F |
| 1312104065 |  | Cavity#32 VTA Run | 5d | 2011-03-02 | 2011-03-08 | 1312104060 FS-2d | 99d | 0d | MECH ENG [8 h]; MECH TECH [8 h]; SCIENTIST [8 h]; COMP SCIENT [8 h]; ELEC ENG [8 h]; ELEC TECH [8 h]; MECH DES [8 h]; SR STAFF [8 h] | 4,083.04 | HOGAN J | 1 | 1 | JOHN H | 08-050 | 09-017 | 09-032 | 09-032 | 10-023 | 10-027 | 10-064 | 11-003 | 11-012 | 11-051 | 12-018F |

| ID | WBS | Activity | Duration | Start | Finish | Predecessors | Total float | Free float | Resources | Cost | RESP - Responsibility | STRT%COMP for CM EVM | FNSH%COMP for CM EVM | CAM RESPONSIBLE | CR 08-050 | CR 09-017 | CR 09-032 | CR 09-032 Repair | CR 10-023 | CR 10-027 | CR 10-064 | CR 11-003 | CR 11-012 | CR 11-051 | CR 12-018 |
| --- | --- | --- | --- | --- | --- | --- | --- | --- | --- | --- | --- | --- | --- | --- | --- | --- | --- | --- | --- | --- | --- | --- | --- | --- | --- |
|  | 05 | **1.3.1.2.1.05 CAVITY STRING #5 PREPARATION** |  | 2011-02-15 | 2011-04-13 |  |  |  |  |  |  |  |  |  |  |  |  |  |  |  |  |  |  |  |  |
| 1312105005 |  | Cavity String #5 Cavity Process & He Vs Weld | 16d | 2011-02-15 | 2011-03-09 | 131114095, 1312104005, 1311122065, 1311122035 | 108d | 7d | MECH ENG [20.4 h]; MECH TECH [298 h]; SUPPLIES & MATERIALS; ELEC TECH [8 h]; MECH DES [4 h] | 24,861.92 | HOGAN J | 1 | 1 | JOHN H | 08-050 | 09-017 | 09-032 | 09-032 | 10-023 | 10-027 | 10-064 | 11-003 | 11-012 | 11-051 | 12-018F |
| 1312105030 |  | Cavity #33 VTA Run | 5d | 2011-03-09 | 2011-03-15 | 1312104065, 1312105005 FS-10d | 99d | 0d | COMP SCIENT [8 h]; ELEC ENG [8 h]; ELEC TECH [8 h]; MECH DES [8 h]; MECH ENG [8 h]; MECH TECH [8 h]; SCIENTIST [8 h]; SR STAFF [8 h] | 4,083.04 | HOGAN J | 1 | 1 | JOHN H | 08-050 | 09-017 | 09-032 | 09-032 | 10-023 | 10-027 | 10-064 | 11-003 | 11-012 | 11-051 | 12-018F |
| 1312105035 |  | Cavity #34 VTA Run | 5d | 2011-03-14 | 2011-03-18 | 1312105030 FS-2d | 99d | 0d | ELEC ENG [8 h]; ELEC TECH [8 h]; MECH DES [8 h]; MECH ENG [8 h]; MECH TECH [8 h]; SCIENTIST [8 h]; SR STAFF [8 h]; COMP SCIENT [8 h] | 4,083.04 | HOGAN J | 1 | 1 | JOHN H | 08-050 | 09-017 | 09-032 | 09-032 | 10-023 | 10-027 | 10-064 | 11-003 | 11-012 | 11-051 | 12-018F |
| 1312105040 |  | Cavity #35 VTA Run | 5d | 2011-03-17 | 2011-03-23 | 1312105035 FS-2d | 99d | 0d | SCIENTIST [8 h]; SR STAFF [8 h]; COMP SCIENT [8 h]; ELEC ENG [8 h]; ELEC TECH [8 h]; MECH DES [8 h]; MECH ENG [8 h]; MECH TECH [8 h] | 4,083.04 | HOGAN J | 1 | 1 | JOHN H | 08-050 | 09-017 | 09-032 | 09-032 | 10-023 | 10-027 | 10-064 | 11-003 | 11-012 | 11-051 | 12-018F |
| 1312105045 |  | Cavity #36 VTA Run | 5d | 2011-03-22 | 2011-03-28 | 1312105040 FS-2d | 99d | 0d | MECH DES [8 h]; MECH ENG [8 h]; MECH TECH [8 h]; SCIENTIST [8 h]; SR STAFF [8 h]; COMP SCIENT [8 h]; ELEC ENG [8 h]; ELEC TECH [8 h] | 4,083.04 | HOGAN J | 1 | 1 | JOHN H | 08-050 | 09-017 | 09-032 | 09-032 | 10-023 | 10-027 | 10-064 | 11-003 | 11-012 | 11-051 | 12-018F |
| 1312105050 |  | Cavity #37 VTA Run | 5d | 2011-03-25 | 2011-03-31 | 1312105045 FS-2d | 99d | 0d | MECH ENG [8 h]; MECH TECH [8 h]; SR STAFF [8 h]; COMP SCIENT [8 h]; ELEC ENG [8 h]; ELEC TECH [8 h]; MECH DES [8 h]; SCIENTIST [8 h] | 4,083.04 | HOGAN J | 1 | 1 | JOHN H | 08-050 | 09-017 | 09-032 | 09-032 | 10-023 | 10-027 | 10-064 | 11-003 | 11-012 | 11-051 | 12-018F |
| 1312105055 |  | Cavity #38 VTA Run | 5d | 2011-03-30 | 2011-04-05 | 1312105050 FS-2d | 99d | 0d | ELEC ENG [8 h]; SR STAFF [8 h]; SCIENTIST [8 h]; COMP SCIENT [8 h]; ELEC TECH [8 h]; MECH DES [8 h]; MECH ENG [8 h]; MECH TECH [8 h] | 4,083.04 | HOGAN J | 1 | 1 | JOHN H | 08-050 | 09-017 | 09-032 | 09-032 | 10-023 | 10-027 | 10-064 | 11-003 | 11-012 | 11-051 | 12-018F |
| 1312105060 |  | Cavity #39 VTA Run | 5d | 2011-04-04 | 2011-04-08 | 1312105055 FS-2d | 99d | 0d | MECH ENG [8 h]; MECH TECH [8 h]; SR STAFF [8 h]; COMP SCIENT [8 h]; ELEC ENG [8 h]; ELEC TECH [8 h]; MECH DES [8 h]; SCIENTIST [8 h] | 4,083.04 | HOGAN J | 1 | 1 | JOHN H | 08-050 | 09-017 | 09-032 | 09-032 | 10-023 | 10-027 | 10-064 | 11-003 | 11-012 | 11-051 | 12-018F |
| 1312105065 |  | Cavity #40 VTA Run | 5d | 2011-04-07 | 2011-04-13 | 1312105060 FS-2d | 99d | 0d | SR STAFF [8 h]; COMP SCIENT [8 h]; ELEC ENG [8 h]; ELEC TECH [8 h]; MECH DES [8 h]; MECH ENG [8 h]; MECH TECH [8 h]; SCIENTIST [8 h] | 4,083.04 | HOGAN J | 1 | 1 | JOHN H | 08-050 | 09-017 | 09-032 | 09-032 | 10-023 | 10-027 | 10-064 | 11-003 | 11-012 | 11-051 | 12-018F |
|  | 06 | **1.3.1.2.1.06 CAVITY STRING #6 PREPARATION** |  | 2011-03-21 | 2011-05-17 |  |  |  |  |  |  |  |  |  |  |  |  |  |  |  |  |  |  |  |  |
| 1312106005 |  | Cavity String #6 Cavity Process & He Vs Weld | 16d | 2011-03-21 | 2011-04-11 | 131114100, 1311122070, 1311122067, 1312105005 | 109d | 6d | MECH ENG [20.4 h]; MECH TECH [298 h]; SUPPLIES & MATERIALS; ELEC TECH [8 h]; MECH DES [4 h] | 24,861.92 | HOGAN J | 1 | 1 | JOHN H | 08-050 | 09-017 | 09-032 | 09-032 |  | 10-027 | 10-064 | 11-003 | 11-012 | 11-051 | 12-018F |
| 1312106030 |  | Cavity #41 VTA Run | 5d | 2011-04-12 | 2011-04-18 | 1312106005 FS-10d, 1312105065 FS-2d | 99d | 0d | ELEC TECH [8 h]; MECH DES [8 h]; MECH ENG [8 h]; MECH TECH [8 h]; SCIENTIST [8 h]; SR STAFF [8 h]; COMP SCIENT [8 h]; ELEC ENG [8 h] | 4,083.04 | HOGAN J | 1 | 1 | JOHN H | 08-050 | 09-017 | 09-032 | 09-032 | 10-023 | 10-027 | 10-064 | 11-003 | 11-012 | 11-051 | 12-018F |
| 1312106035 |  | Cavity #42 VTA Run | 5d | 2011-04-15 | 2011-04-21 | 1312106030 FS-2d | 99d | 0d | SR STAFF [8 h]; COMP SCIENT [8 h]; ELEC ENG [8 h]; ELEC TECH [8 h]; MECH DES [8 h]; MECH ENG [8 h]; MECH TECH [8 h]; SCIENTIST [8 h] | 4,083.04 | HOGAN J | 1 | 1 | JOHN H | 08-050 | 09-017 | 09-032 | 09-032 | 10-023 | 10-027 | 10-064 | 11-003 | 11-012 | 11-051 | 12-018F |
| 1312106040 |  | Cavity #43 VTA Run | 5d | 2011-04-20 | 2011-04-26 | 1312106035 FS-2d | 99d | 0d | ELEC ENG [8 h]; ELEC TECH [8 h]; MECH DES [8 h]; MECH ENG [8 h]; MECH TECH [8 h]; SCIENTIST [8 h]; SR STAFF [8 h]; COMP SCIENT [8 h] | 4,083.04 | HOGAN J | 1 | 1 | JOHN H | 08-050 | 09-017 | 09-032 | 09-032 | 10-023 | 10-027 | 10-064 | 11-003 | 11-012 | 11-051 | 12-018F |
| 1312106045 |  | Cavity #44 VTA Run | 5d | 2011-04-25 | 2011-04-29 | 1312106040 FS-2d | 99d | 0d | SCIENTIST [8 h]; SR STAFF [8 h]; COMP SCIENT [8 h]; ELEC ENG [8 h]; ELEC TECH [8 h]; MECH DES [8 h]; MECH ENG [8 h]; MECH TECH [8 h] | 4,083.04 | HOGAN J | 1 | 1 | JOHN H | 08-050 | 09-017 | 09-032 | 09-032 | 10-023 | 10-027 | 10-064 | 11-003 | 11-012 | 11-051 | 12-018F |
| 1312106050 |  | Cavity #45 VTA Run | 5d | 2011-04-28 | 2011-05-04 | 1312106045 FS-2d | 99d | 0d | MECH DES [8 h]; MECH ENG [8 h]; MECH TECH [8 h]; SCIENTIST [8 h]; SR STAFF [8 h]; COMP SCIENT [8 h]; ELEC ENG [8 h]; ELEC TECH [8 h] | 4,083.04 | HOGAN J | 1 | 1 | JOHN H | 08-050 | 09-017 | 09-032 | 09-032 | 10-023 | 10-027 | 10-064 | 11-003 | 11-012 | 11-051 | 12-018F |
| 1312106055 |  | Cavity #46 VTA Run | 5d | 2011-05-03 | 2011-05-09 | 1312106050 FS-2d | 99d | 0d | MECH TECH [8 h]; SCIENTIST [8 h]; SR STAFF [8 h]; COMP SCIENT [8 h]; ELEC ENG [8 h]; ELEC TECH [8 h]; MECH DES [8 h]; MECH ENG [8 h] | 4,083.04 | HOGAN J | 1 | 1 | JOHN H | 08-050 | 09-017 | 09-032 | 09-032 | 10-023 | 10-027 | 10-064 | 11-003 | 11-012 | 11-051 | 12-018F |
| 1312106060 |  | Cavity #47 VTA Run | 5d | 2011-05-06 | 2011-05-12 | 1312106055 FS-2d | 99d | 0d | SCIENTIST [8 h]; SR STAFF [8 h]; COMP SCIENT [8 h]; ELEC ENG [8 h]; ELEC TECH [8 h]; MECH DES [8 h]; MECH ENG [8 h]; MECH TECH [8 h] | 4,083.04 | HOGAN J | 1 | 1 | JOHN H | 08-050 | 09-017 | 09-032 | 09-032 | 10-023 | 10-027 | 10-064 | 11-003 | 11-012 | 11-051 | 12-018F |
| 1312106065 |  | Cavity #48 VTA Run | 5d | 2011-05-11 | 2011-05-17 | 1312106060 FS-2d | 99d | 0d | SR STAFF [8 h]; ELEC ENG [8 h]; ELEC TECH [8 h]; COMP SCIENT [8 h]; MECH DES [8 h]; MECH ENG [8 h]; MECH TECH [8 h]; SCIENTIST [8 h] | 4,083.04 | HOGAN J | 1 | 1 | JOHN H | 08-050 | 09-017 | 09-032 | 09-032 | 10-023 | 10-027 | 10-064 | 11-003 | 11-012 | 11-051 | 12-018F |
|  | 07 | **1.3.1.2.1.07 CAVITY STRING #7 PREPARATION** |  | 2011-04-20 | 2011-06-21 |  |  |  |  |  |  |  |  |  |  |  |  |  |  |  |  |  |  |  |  |
| 1312107005 |  | Cavity String #7 Cavity Process & He Vs Weld | 16d | 2011-04-20 | 2011-05-11 | 1312106005, 1311122075, 131114105, 1311122072 | 111d | 12d | MECH DES [4 h]; MECH ENG [20.4 h]; MECH TECH [298 h]; SUPPLIES & MATERIALS; ELEC TECH [8 h] | 24,861.92 | HOGAN J | 1 | 1 | JOHN H | 08-050 | 09-017 | 09-032 | 09-032 |  | 10-027 | 10-064 | 11-003 | 11-012 | 11-051 | 12-018F |
| 1312107030 |  | Cavity #49 VTA Run | 5d | 2011-05-16 | 2011-05-20 | 1312107005 FS-10d, 1312106065 FS-2d | 99d | 0d | MECH ENG [8 h]; MECH TECH [8 h]; SCIENTIST [8 h]; SR STAFF [8 h]; COMP SCIENT [8 h]; ELEC ENG [8 h]; ELEC TECH [8 h]; MECH DES [8 h] | 4,083.04 | HOGAN J | 1 | 1 | JOHN H | 08-050 | 09-017 | 09-032 | 09-032 | 10-023 | 10-027 | 10-064 | 11-003 | 11-012 | 11-051 | 12-018F |
| 1312107035 |  | Cavity #50 VTA Run | 5d | 2011-05-19 | 2011-05-25 | 1312107030 FS-2d | 99d | 0d | MECH TECH [8 h]; SCIENTIST [8 h]; SR STAFF [8 h]; COMP SCIENT [8 h]; ELEC ENG [8 h]; ELEC TECH [8 h]; MECH DES [8 h]; MECH ENG [8 h] | 4,083.04 | HOGAN J | 1 | 1 | JOHN H | 08-050 | 09-017 | 09-032 | 09-032 | 10-023 | 10-027 | 10-064 | 11-003 | 11-012 | 11-051 | 12-018F |
| 1312107040 |  | Cavity #51 VTA Run | 5d | 2011-05-24 | 2011-05-31 | 1312107035 FS-2d | 99d | 0d | MECH ENG [8 h]; MECH TECH [8 h]; SCIENTIST [8 h]; SR STAFF [8 h]; COMP SCIENT [8 h]; ELEC ENG [8 h]; ELEC TECH [8 h]; MECH DES [8 h] | 4,083.04 | HOGAN J | 1 | 1 | JOHN H | 08-050 | 09-017 | 09-032 | 09-032 | 10-023 | 10-027 | 10-064 | 11-003 | 11-012 | 11-051 | 12-018F |
| 1312107045 |  | Cavity #52 VTA Run | 5d | 2011-05-27 | 2011-06-03 | 1312107040 FS-2d | 99d | 0d | SR STAFF [8 h]; COMP SCIENT [8 h]; ELEC ENG [8 h]; ELEC TECH [8 h]; MECH DES [8 h]; MECH TECH [8 h]; MECH ENG [8 h]; SCIENTIST [8 h] | 4,083.04 | HOGAN J | 1 | 1 | JOHN H | 08-050 | 09-017 | 09-032 | 09-032 | 10-023 | 10-027 | 10-064 | 11-003 | 11-012 | 11-051 | 12-018F |
| 1312107050 |  | Cavity #53 VTA Run | 5d | 2011-06-02 | 2011-06-08 | 1312107045 FS-2d | 99d | 0d | SCIENTIST [8 h]; SR STAFF [8 h]; COMP SCIENT [8 h]; ELEC ENG [8 h]; ELEC TECH [8 h]; MECH DES [8 h]; MECH ENG [8 h]; MECH TECH [8 h] | 4,083.04 | HOGAN J | 1 | 1 | JOHN H | 08-050 | 09-017 | 09-032 | 09-032 | 10-023 | 10-027 | 10-064 | 11-003 | 11-012 | 11-051 | 12-018F |
| 1312107055 |  | Cavity #54 VTA Run | 5d | 2011-06-07 | 2011-06-13 | 1312107050 FS-2d | 99d | 0d | MECH DES [8 h]; MECH ENG [8 h]; MECH TECH [8 h]; ELEC ENG [8 h]; SCIENTIST [8 h]; SR STAFF [8 h]; COMP SCIENT [8 h]; ELEC TECH [8 h] | 4,083.04 | HOGAN J | 1 | 1 | JOHN H | 08-050 | 09-017 | 09-032 | 09-032 | 10-023 | 10-027 | 10-064 | 11-003 | 11-012 | 11-051 | 12-018F |
| 1312107060 |  | Cavity #55 VTA Run | 5d | 2011-06-10 | 2011-06-16 | 1312107055 FS-2d | 99d | 0d | COMP SCIENT [8 h]; ELEC ENG [8 h]; ELEC TECH [8 h]; SR STAFF [8 h]; MECH DES [8 h]; MECH ENG [8 h]; MECH TECH [8 h]; SCIENTIST [8 h] | 4,083.04 | HOGAN J | 1 | 1 | JOHN H | 08-050 | 09-017 | 09-032 | 09-032 | 10-023 | 10-027 | 10-064 | 11-003 | 11-012 | 11-051 | 12-018F |
| 1312107065 |  | Cavity #56 VTA Run | 5d | 2011-06-15 | 2011-06-21 | 1312107060 FS-2d | 99d | 0d | MECH DES [8 h]; MECH ENG [8 h]; MECH TECH [8 h]; SCIENTIST [8 h]; SR STAFF [8 h]; COMP SCIENT [8 h]; ELEC ENG [8 h]; ELEC TECH [8 h] | 4,083.04 | HOGAN J | 1 | 1 | JOHN H | 08-050 | 09-017 | 09-032 | 09-032 | 10-023 | 10-027 | 10-064 | 11-003 | 11-012 | 11-051 | 12-018F |

| ID | WBS | Activity | Duration | Start | Finish | Predecessors | Total float | Free float | Resources | Cost | RESP - Responsibility | STRT%COMP for CM EVM | FNSH%COMP for CM EVM | CAM RESPONSIBLE | CR 08-050 | CR 09-017 | CR 09-032 | CR 09-032 Repair | CR 10-027 | CR 10-064 | CR 11-003 | CR 11-012 | CR 11-051 | CR 12-018 | CR 10-023 |
| --- | --- | --- | --- | --- | --- | --- | --- | --- | --- | --- | --- | --- | --- | --- | --- | --- | --- | --- | --- | --- | --- | --- | --- | --- | --- |
|  | 08 | **1.3.1.2.1.08 CAVITY STRING #8 PREPARATION** |  | 2011-06-02 | 2011-08-26 |  |  |  |  |  |  |  |  |  |  |  |  |  |  |  |  |  |  |  |  |
| 1312108005 |  | Cavity String #8 Cavity Process & He Vs Weld | 16d | 2011-06-02 | 2011-06-23 | 1311122080, 1311122085, 1312107005, 131114110 | 105d | 6d | SUPPLIES & MATERIALS; ELEC TECH [8 h]; MECH DES [4 h]; MECH ENG [20.4 h]; MECH TECH [298 h] | 24,861.92 | HOGAN J | 1 | 1 | JOHN H | 08-050 | 09-017 | 09-032 | 09-032 | 10-027 | 10-064 | 11-003 | 11-012 | 11-051 | 12-018F |  |
| 1312108030 |  | Cavity #57 VTA Run | 5d | 2011-06-20 | 2011-06-24 | 1312108005 FS-10d, 1312107065 FS-2d | 99d | 0d | COMP SCIENT [8 h]; ELEC ENG [8 h]; ELEC TECH [8 h]; MECH DES [8 h]; MECH ENG [8 h]; MECH TECH [8 h]; SCIENTIST [8 h]; SR STAFF [8 h] | 4,083.04 | HOGAN J | 1 | 1 | JOHN H | 08-050 | 09-017 | 09-032 | 09-032 | 10-027 | 10-064 | 11-003 | 11-012 | 11-051 | 12-018F |  |
| 1312108035 |  | Cavity #58 VTA Run | 5d | 2011-06-23 | 2011-06-29 | 1312108030 FS-2d | 99d | 1d | MECH TECH [8 h]; SCIENTIST [8 h]; SR STAFF [8 h]; COMP SCIENT [8 h]; ELEC ENG [8 h]; ELEC TECH [8 h]; MECH DES [8 h]; MECH ENG [8 h] | 4,083.04 | HOGAN J | 1 | 1 | JOHN H | 08-050 | 09-017 | 09-032 | 09-032 | 10-027 | 10-064 | 11-003 | 11-012 | 11-051 | 12-018F | 10-023 |
| 1312108040 |  | Cavity #59 VTA Run | 5d | 2011-08-01 | 2011-08-05 | 1317010, 1312108035 FS-2d | 107d | 0d | SR STAFF [8 h]; COMP SCIENT [8 h]; ELEC ENG [8 h]; ELEC TECH [8 h]; MECH DES [8 h]; MECH ENG [8 h]; MECH TECH [8 h]; SCIENTIST [8 h] | 4,083.04 | HOGAN J | 1 | 1 | JOHN H | 08-050 | 09-017 | 09-032 | 09-032 | 10-027 | 10-064 | 11-003 | 11-012 | 11-051 | 12-018F | 10-023 |
| 1312108045 |  | Cavity #60 VTA Run | 5d | 2011-08-04 | 2011-08-10 | 1312108040 FS-2d | 107d | 0d | SCIENTIST [8 h]; SR STAFF [8 h]; COMP SCIENT [8 h]; ELEC ENG [8 h]; ELEC TECH [8 h]; MECH DES [8 h]; MECH ENG [8 h]; MECH TECH [8 h] | 4,083.04 | HOGAN J | 1 | 1 | JOHN H | 08-050 | 09-017 | 09-032 | 09-032 | 10-027 | 10-064 | 11-003 | 11-012 | 11-051 | 12-018F | 10-023 |
| 1312108050 |  | Cavity #61 VTA Run | 5d | 2011-08-09 | 2011-08-15 | 1312108045 FS-2d | 107d | 0d | COMP SCIENT [8 h]; ELEC ENG [8 h]; ELEC TECH [8 h]; MECH DES [8 h]; MECH ENG [8 h]; MECH TECH [8 h]; SCIENTIST [8 h]; SR STAFF [8 h] | 4,083.04 | HOGAN J | 1 | 1 | JOHN H | 08-050 | 09-017 | 09-032 | 09-032 | 10-027 | 10-064 | 11-003 | 11-012 | 11-051 | 12-018F | 10-023 |
| 1312108055 |  | Cavity #62 VTA Run | 5d | 2011-08-12 | 2011-08-18 | 1312108050 FS-2d | 107d | 0d | MECH ENG [8 h]; MECH TECH [8 h]; SCIENTIST [8 h]; SR STAFF [8 h]; COMP SCIENT [8 h]; ELEC TECH [8 h]; MECH DES [8 h]; ELEC ENG [8 h] | 4,083.04 | HOGAN J | 1 | 1 | JOHN H | 08-050 | 09-017 | 09-032 | 09-032 | 10-027 | 10-064 | 11-003 | 11-012 | 11-051 | 12-018F | 10-023 |
| 1312108060 |  | Cavity #63 VTA Run | 5d | 2011-08-17 | 2011-08-23 | 1312108055 FS-2d | 107d | 0d | COMP SCIENT [8 h]; ELEC ENG [8 h]; ELEC TECH [8 h]; MECH DES [8 h]; MECH ENG [8 h]; MECH TECH [8 h]; SCIENTIST [8 h]; SR STAFF [8 h] | 4,083.04 | HOGAN J | 1 | 1 | JOHN H | 08-050 | 09-017 | 09-032 | 09-032 | 10-027 | 10-064 | 11-003 | 11-012 | 11-051 | 12-018F | 10-023 |
| 1312108065 |  | Cavity #64 VTA Run | 5d | 2011-08-22 | 2011-08-26 | 1312108060 FS-2d | 107d | 0d | MECH DES [8 h]; MECH ENG [8 h]; MECH TECH [8 h]; SCIENTIST [8 h]; SR STAFF [8 h]; COMP SCIENT [8 h]; ELEC ENG [8 h]; ELEC TECH [8 h] | 4,083.04 | HOGAN J | 1 | 1 | JOHN H | 08-050 | 09-017 | 09-032 | 09-032 | 10-027 | 10-064 | 11-003 | 11-012 | 11-051 | 12-018F | 10-023 |
|  | 09 | **1.3.1.2.1.09 CAVITY STRING #9 PREPARATION** |  | 2011-08-15 | 2011-09-30 |  |  |  |  |  |  |  |  |  |  |  |  |  |  |  |  |  |  |  |  |
| 1312109005 |  | Cavity String #9 Cavity Process & He Vs Weld | 16d | 2011-08-15 | 2011-09-06 | 131114115, 1312108005, 1311122087, 1311122090 | 109d | 2d | MECH DES [4 h]; MECH ENG [20.4 h]; MECH TECH [298 h]; SUPPLIES & MATERIALS; ELEC TECH [8 h] | 24,861.92 | HOGAN J | 1 | 1 | JOHN H | 08-050 | 09-017 | 09-032 | 09-032 | 10-027 | 10-064 | 11-003 | 11-012 | 11-051 | 12-018F |  |
| 1312109030 |  | Cavity #65 VTA Run | 5d | 2011-08-25 | 2011-08-31 | 1312108065 FS-2d, 1312109005 FS-10d | 107d | 0d | SCIENTIST [8 h]; SR STAFF [8 h]; COMP SCIENT [8 h]; ELEC ENG [8 h]; ELEC TECH [8 h]; MECH DES [8 h]; MECH ENG [8 h]; MECH TECH [8 h] | 4,083.04 | HOGAN J | 1 | 1 | JOHN H | 08-050 | 09-017 | 09-032 | 09-032 | 10-027 | 10-064 | 11-003 |  | 11-051 | 12-018F |  |
| 1312109035 |  | Cavity #66 VTA Run | 5d | 2011-08-30 | 2011-09-06 | 1312109030 FS-2d | 107d | 0d | SCIENTIST [8 h]; SR STAFF [8 h]; COMP SCIENT [8 h]; ELEC ENG [8 h]; ELEC TECH [8 h]; MECH DES [8 h]; MECH ENG [8 h]; MECH TECH [8 h] | 4,083.04 | HOGAN J | 1 | 1 | JOHN H | 08-050 | 09-017 | 09-032 | 09-032 | 10-027 | 10-064 | 11-003 |  | 11-051 | 12-018F | 10-023 |
| 1312109040 |  | Cavity #67 VTA Run | 5d | 2011-09-02 | 2011-09-09 | 1312109035 FS-2d | 107d | 0d | MECH ENG [8 h]; MECH TECH [8 h]; SCIENTIST [8 h]; SR STAFF [8 h]; COMP SCIENT [8 h]; ELEC ENG [8 h]; ELEC TECH [8 h]; MECH DES [8 h] | 4,083.04 | HOGAN J | 1 | 1 | JOHN H | 08-050 | 09-017 | 09-032 | 09-032 | 10-027 | 10-064 | 11-003 |  | 11-051 | 12-018F | 10-023 |
| 1312109045 |  | Cavity #68 VTA Run | 5d | 2011-09-08 | 2011-09-14 | 1312109040 FS-2d | 107d | 0d | ELEC ENG [8 h]; ELEC TECH [8 h]; MECH DES [8 h]; MECH ENG [8 h]; MECH TECH [8 h]; SCIENTIST [8 h]; SR STAFF [8 h]; COMP SCIENT [8 h] | 4,083.04 | HOGAN J | 1 | 1 | JOHN H | 08-050 | 09-017 | 09-032 | 09-032 | 10-027 | 10-064 | 11-003 |  | 11-051 | 12-018F | 10-023 |
| 1312109050 |  | Cavity #69 VTA Run | 5d | 2011-09-13 | 2011-09-19 | 1312109045 FS-2d | 107d | 0d | MECH ENG [8 h]; MECH TECH [8 h]; SCIENTIST [8 h]; SR STAFF [8 h]; ELEC ENG [8 h]; COMP SCIENT [8 h]; ELEC TECH [8 h]; MECH DES [8 h] | 4,083.04 | HOGAN J | 1 | 1 | JOHN H | 08-050 | 09-017 | 09-032 | 09-032 | 10-027 | 10-064 | 11-003 |  | 11-051 | 12-018F | 10-023 |
| 1312109055 |  | Cavity #70 VTA Run | 5d | 2011-09-16 | 2011-09-22 | 1312109050 FS-2d | 107d | 0d | MECH DES [8 h]; MECH ENG [8 h]; MECH TECH [8 h]; SCIENTIST [8 h]; SR STAFF [8 h]; COMP SCIENT [8 h]; ELEC ENG [8 h]; ELEC TECH [8 h] | 4,083.04 | HOGAN J | 1 | 1 | JOHN H | 08-050 | 09-017 | 09-032 | 09-032 | 10-027 | 10-064 | 11-003 |  | 11-051 | 12-018F | 10-023 |
| 1312109060 |  | Cavity #71 VTA Run | 5d | 2011-09-21 | 2011-09-27 | 1312109055 FS-2d | 107d | 0d | ELEC TECH [8 h]; MECH DES [8 h]; MECH ENG [8 h]; SCIENTIST [8 h]; SR STAFF [8 h]; COMP SCIENT [8 h]; MECH TECH [8 h]; ELEC ENG [8 h] | 4,083.04 | HOGAN J | 1 | 1 | JOHN H | 08-050 | 09-017 | 09-032 | 09-032 | 10-027 | 10-064 | 11-003 |  | 11-051 | 12-018F | 10-023 |
| 1312109065 |  | Cavity #72 VTA Run | 5d | 2011-09-26 | 2011-09-30 | 1312109060 FS-2d | 107d | 9d | MECH ENG [8 h]; MECH TECH [8 h]; SCIENTIST [8 h]; SR STAFF [8 h]; COMP SCIENT [8 h]; ELEC ENG [8 h]; ELEC TECH [8 h]; MECH DES [8 h] | 4,083.04 | HOGAN J | 1 | 1 | JOHN H | 08-050 | 09-017 | 09-032 | 09-032 | 10-027 | 10-064 | 11-003 |  | 11-051 | 12-018F | 10-023 |
|  | 10 | **1.3.1.2.1.10 CAVITY STRING #10 PREPARATION** |  | 2011-10-04 | 2011-11-16 |  |  |  |  |  |  |  |  |  |  |  |  |  |  |  |  |  |  |  |  |
| 1312110005 |  | Cavity String #10 Cavity Process & He Vs Weld | 16d | 2011-10-04 | 2011-10-25 | 1311122092, 1311122095, 131114130M, 131114125, 1312109005, 131114120, 1311122100a | 98d | 0d | ELEC TECH [8 h]; MECH DES [4 h]; MECH ENG [20.4 h]; MECH TECH [298 h]; SUPPLIES & MATERIALS | 25,653.86 | HOGAN J | 1 | 1 | JOHN H | 08-050 | 09-017 | 09-032 | 09-032 | 10-027 | 10-064 | 11-003 | 11-012 | 11-051 | 12-018F |  |
| 1312110030 |  | Cavity #73 VTA Run | 5d | 2011-10-12 | 2011-10-18 | 1312110005 FS-10d, 1312109065 FS-2d | 98d | 0d | MECH TECH [8 h]; SCIENTIST [8 h]; SR STAFF [8 h]; COMP SCIENT [8 h]; ELEC ENG [8 h]; ELEC TECH [8 h]; MECH DES [8 h]; MECH ENG [8 h] | 4,213.2 | HOGAN J | 1 | 1 | JOHN H | 08-050 | 09-017 | 09-032 | 09-032 | 10-027 | 10-064 | 11-003 | 11-012 | 11-051 | 12-018F |  |
| 1312110035 |  | Cavity #74 VTA Run | 5d | 2011-10-17 | 2011-10-21 | 1312110030 FS-2d | 98d | 0d | MECH DES [8 h]; MECH ENG [8 h]; MECH TECH [8 h]; SCIENTIST [8 h]; SR STAFF [8 h]; COMP SCIENT [8 h]; ELEC ENG [8 h]; ELEC TECH [8 h] | 4,213.2 | HOGAN J | 1 | 1 | JOHN H | 08-050 | 09-017 | 09-032 | 09-032 | 10-027 | 10-064 | 11-003 | 11-012 | 11-051 | 12-018F | 10-023 |
| 1312110040 |  | Cavity #75 VTA Run | 5d | 2011-10-20 | 2011-10-26 | 1312110035 FS-2d | 98d | 0d | SCIENTIST [8 h]; SR STAFF [8 h]; COMP SCIENT [8 h]; ELEC ENG [8 h]; ELEC TECH [8 h]; MECH DES [8 h]; MECH ENG [8 h]; MECH TECH [8 h] | 4,213.2 | HOGAN J | 1 | 1 | JOHN H | 08-050 | 09-017 | 09-032 | 09-032 | 10-027 | 10-064 | 11-003 | 11-012 | 11-051 | 12-018F | 10-023 |
| 1312110045 |  | Cavity #76 VTA Run | 5d | 2011-10-25 | 2011-10-31 | 1312110040 FS-2d | 98d | 0d | MECH DES [8 h]; MECH ENG [8 h]; MECH TECH [8 h]; SCIENTIST [8 h]; SR STAFF [8 h]; COMP SCIENT [8 h]; ELEC ENG [8 h]; ELEC TECH [8 h] | 4,213.2 | HOGAN J | 1 | 1 | JOHN H | 08-050 | 09-017 | 09-032 | 09-032 | 10-027 | 10-064 | 11-003 | 11-012 | 11-051 | 12-018F | 10-023 |
| 1312110050 |  | Cavity #77 VTA Run | 5d | 2011-10-28 | 2011-11-03 | 1312110045 FS-2d | 98d | 0d | MECH TECH [8 h]; SCIENTIST [8 h]; SR STAFF [8 h]; COMP SCIENT [8 h]; ELEC ENG [8 h]; ELEC TECH [8 h]; MECH DES [8 h]; MECH ENG [8 h] | 4,213.2 | HOGAN J | 1 | 1 | JOHN H | 08-050 | 09-017 | 09-032 | 09-032 | 10-027 | 10-064 | 11-003 | 11-012 | 11-051 | 12-018F | 10-023 |
| 1312110055 |  | Cavity #78 VTA Run | 5d | 2011-11-02 | 2011-11-08 | 1312110050 FS-2d | 98d | 0d | COMP SCIENT [8 h]; ELEC ENG [8 h]; ELEC TECH [8 h]; MECH DES [8 h]; MECH ENG [8 h]; MECH TECH [8 h]; SCIENTIST [8 h]; SR STAFF [8 h] | 4,213.2 | HOGAN J | 1 | 1 | JOHN H | 08-050 | 09-017 | 09-032 | 09-032 | 10-027 | 10-064 | 11-003 | 11-012 | 11-051 | 12-018F | 10-023 |
| 1312110060 |  | Cavity #79 VTA Run | 5d | 2011-11-07 | 2011-11-11 | 1312110055 FS-2d | 98d | 0d | ELEC ENG [8 h]; ELEC TECH [8 h]; MECH DES [8 h]; MECH ENG [8 h]; MECH TECH [8 h]; SCIENTIST [8 h]; SR STAFF [8 h]; COMP SCIENT [8 h] | 4,213.2 | HOGAN J | 1 | 1 | JOHN H | 08-050 | 09-017 | 09-032 | 09-032 | 10-027 | 10-064 | 11-003 | 11-012 | 11-051 | 12-018F | 10-023 |
| 1312110065 |  | Cavity #80 VTA Run | 5d | 2011-11-10 | 2011-11-16 | 1312110060 FS-2d | 98d | 48d | COMP SCIENT [8 h]; ELEC ENG [8 h]; ELEC TECH [8 h]; MECH DES [8 h]; MECH ENG [8 h]; MECH TECH [8 h]; SCIENTIST [8 h]; SR STAFF [8 h] | 4,213.2 | HOGAN J | 1 | 1 | JOHN H | 08-050 | 09-017 | 09-032 | 09-032 | 10-027 | 10-064 | 11-003 | 11-012 | 11-051 | 12-018F | 10-023 |

| ID | WBS | Activity | Duration | Start | Finish | Predecessors | Total float | Free float | Resources | Cost | RESP - Responsibility | STRT%COMP for CM EVM | FNSH%COMP for CM EVM | Profile change | CAM RESPONSIBLE | CR 08-050 | CR 09-017 | CR 09-032 | CR 09-032 Repair | CR 10-027 | CR 10-064 | CR 11-003 | CR 11-051 | CR 10-023 | CR 11-012 | CR 12-018 | CR 12-028 | CR 10-066 |
| --- | --- | --- | --- | --- | --- | --- | --- | --- | --- | --- | --- | --- | --- | --- | --- | --- | --- | --- | --- | --- | --- | --- | --- | --- | --- | --- | --- | --- |
|  | 2 | **1.3.1.2.2 DUMMY** |  |  |  |  |  |  |  |  |  |  |  |  |  |  |  |  |  |  |  |  |  |  |  |  |  |  |
|  | 3 | **1.3.1.2.3 DUMMY** |  |  |  |  |  |  |  |  |  |  |  |  |  |  |  |  |  |  |  |  |  |  |  |  |  |  |
|  | 4 | **1.3.1.2.4 STRING ASSEMBLY** |  | 2010-11-01 | 2012-02-21 |  |  |  |  |  |  |  |  |  |  |  |  |  |  |  |  |  |  |  |  |  |  |  |
|  | 01 | **1.3.1.2.4.01 CAVITY STRING ASSEMBLY #1** |  | 2010-11-01 | 2010-11-15 |  |  |  |  |  |  |  |  |  |  |  |  |  |  |  |  |  |  |  |  |  |  |  |
| 1312401000 |  | Cavity String Assy #1 | 10d | 2010-11-01 | 2010-11-12 | 1312101030, 1312101035, 131116015, 1312101065 FS+10d, 1312101060, 1312101050a, 131115015, 1312101040, 1312101045, 131137020, 32-03M, 1312101055, 131138040, 1311132010 | 37d | 0d | SR STAFF [20 h]; ELEC ENG [200 h]; MECH DES [80 h]; MECH ENG [80 h]; MECH TECH [1200 h]; ELEC TECH [40 h]; COMP SCIENT [40 h]; SUPPLIES & MATERIALS; SCIENTIST [64 h] | 102,362.07 | HOGAN J | 1 | 1 | C | JOHN H | 08-050 | 09-017 | 09-032 | 09-032 | 10-027 | 10-064 | 11-003 | 11-051 |  |  |  |  |  |
| 1312401010 |  | Transfer to CM #1 Assy | 1d | 2010-11-15 | 2010-11-15 | 1312401000 | 37d | 0d |  |  | HOGAN J | 1 | 1 |  | JOHN H | 08-050 | 09-017 | 09-032 | 09-032 | 10-027 | 10-064 | 11-003 | 11-051 |  |  |  |  |  |
|  | 02 | **1.3.1.2.4.02 CAVITY STRING ASSEMBLY #2** |  | 2010-11-22 | 2011-03-07 |  |  |  |  |  |  |  |  |  |  |  |  |  |  |  |  |  |  |  |  |  |  |  |
| 1312402000 |  | Cavity String Assy #2 | 10d | 2010-11-22 | 2010-12-07 | 1312102045, 1312102055, 1312102050, 1311132020, 1312102040, 1311132015, 1312102030, 1312102060, 1312102035, 1312102065, 1312401010 FS+4d | 37d | 0d | SUPPLIES & MATERIALS; SCIENTIST [64 h]; SR STAFF [20 h]; ELEC ENG [200 h]; ELEC TECH [40 h]; MECH DES [80 h]; MECH ENG [80 h]; MECH TECH [1000 h] | 91,204.47 | HOGAN J | 1 | 1 |  | JOHN H | 08-050 | 09-017 | 09-032 | 09-032 | 10-027 | 10-064 | 11-003 | 11-051 | 10-023 | 11-012 |  |  |  |
| 1312402010 |  | Transfer to CM #2 Assy | 1d | 2011-03-07 | 2011-03-07 | 1312402000 FS+55d | 37d | 0d |  |  | HOGAN J | 1 | 1 |  | JOHN H | 08-050 | 09-017 | 09-032 | 09-032 | 10-027 | 10-064 | 11-003 | 11-051 | 10-023 | 11-012 |  |  |  |
|  | 03 | **1.3.1.2.4.03 CAVITY STRING ASSEMBLY #3** |  | 2011-03-22 | 2011-04-05 |  |  |  |  |  |  |  |  |  |  |  |  |  |  |  |  |  |  |  |  |  |  |  |
| 1312403000 |  | Cavity String Assy #3 | 10d | 2011-03-22 | 2011-04-04 | 1312103065, 1312103035, 1312402010 FS+4d, 1311132025, 1312103050, 131302001, 1312103060, 1312103040, 1311132030, 1312103030, 1312103055, 1312103045 | 114d | 0d | MECH TECH [800 h]; SUPPLIES & MATERIALS; ELEC TECH [40 h]; MECH DES [40 h]; SCIENTIST [64 h]; ELEC ENG [200 h]; SR STAFF [20 h]; MECH ENG [40 h] | 78,005.27 | HOGAN J | 1 | 1 |  | JOHN H | 08-050 | 09-017 | 09-032 | 09-032 | 10-027 | 10-064 | 11-003 | 11-051 |  | 11-012 | 12-018F | 12-028F |  |
| 1312403010 |  | Transfer to CM #3 Assy | 1d | 2011-04-05 | 2011-04-05 | 131302001, 1312403000 | 114d | 0d |  |  | HOGAN J | 1 | 1 |  | JOHN H | 08-050 | 09-017 | 09-032 | 09-032 | 10-027 | 10-064 | 11-003 | 11-051 |  | 11-012 | 12-018F | 12-028F |  |
|  | 04 | **1.3.1.2.4.04 CAVITY STRING ASSEMBLY #4** |  | 2011-05-03 | 2011-05-17 |  |  |  |  |  |  |  |  |  |  |  |  |  |  |  |  |  |  |  |  |  |  |  |
| 1312404000 |  | Cavity String Assy #4 | 10d | 2011-05-03 | 2011-05-16 | 131138045a, 1312104055, 1312104060, 1312104045, 1311132035, 131302002 FS-30d, 1312104065, 1312403010 FS+4d, 1312104040, 1312104030, 1312104035, 1312104050, 1311132040 | 100d | 0d | SUPPLIES & MATERIALS; SR STAFF [20 h]; MECH DES [40 h]; ELEC ENG [200 h]; MECH ENG [40 h]; SCIENTIST [64 h]; ELEC TECH [40 h]; MECH TECH [800 h] | 78,005.27 | HOGAN J | 1 | 1 |  | JOHN H | 08-050 | 09-017 | 09-032 | 09-032 | 10-027 | 10-064 | 11-003 | 11-051 | 10-023 | 11-012 | 12-018F | 12-028F |  |
| 1312404010 |  | Transfer to CM #4 Assy | 1d | 2011-05-17 | 2011-05-17 | 131302002 FS-20d, 1312404000 | 100d | 15d |  |  | HOGAN J | 1 | 1 |  | JOHN H | 08-050 | 09-017 | 09-032 | 09-032 | 10-027 | 10-064 | 11-003 | 11-051 | 10-023 | 11-012 | 12-018F | 12-028F |  |
|  | 05 | **1.3.1.2.4.05 CAVITY STRING ASSEMBLY #5** |  | 2011-05-25 | 2011-06-09 |  |  |  |  |  |  |  |  |  |  |  |  |  |  |  |  |  |  |  |  |  |  |  |
| 1312405000 |  | Cavity String Assy #5 | 10d | 2011-05-25 | 2011-06-08 | 1312105060, 131115016, 131302003 FS-25d, 1312105050, 1312404010 FS-10d, 131116016, 1312105055, 1311132045, 1312105065, 1312105035, 1312105045, 1312105030, 1312105040 | 114d | 0d | MECH TECH [800 h]; SUPPLIES & MATERIALS; MECH ENG [40 h]; SCIENTIST [64 h]; SR STAFF [20 h]; ELEC ENG [200 h]; ELEC TECH [40 h]; MECH DES [40 h] | 78,005.27 | HOGAN J | 1 | 1 |  | JOHN H | 08-050 | 09-017 |  |  | 10-027 | 10-064 | 11-003 | 11-051 |  | 11-012 | 12-018F |  |  |
| 1312405010 |  | Transfer to CM #5 Assy | 1d | 2011-06-09 | 2011-06-09 | 131302003 FS-15d, 1312405000 | 144d | 1d |  |  | HOGAN J | 1 | 1 |  | JOHN H | 08-050 | 09-017 |  |  | 10-027 | 10-064 |  | 11-051 |  | 11-012 | 12-018F | 12-028F | 10-066 |
|  | 06 | **1.3.1.2.4.06 CAVITY STRING ASSEMBLY #6** |  | 2011-06-17 | 2011-11-21 |  |  |  |  |  |  |  |  |  |  |  |  |  |  |  |  |  |  |  |  |  |  |  |
| 1312406000 |  | Cavity String Assy #6 | 10d | 2011-06-17 | 2011-06-30 | 1312106035, 1312106060, 1312106040, 1312106055, 1312405010 FS+4d, 1312106065, 1312106045, 1311132050, 1312106030, 1312106050, 131302004 FS-105d, 1317010 FS-30d | 149d | 99d | MECH ENG [40 h]; ELEC ENG [200 h]; ELEC TECH [40 h]; MECH TECH [800 h]; SUPPLIES & MATERIALS; SCIENTIST [64 h]; SR STAFF [20 h]; MECH DES [40 h] | 78,005.27 | HOGAN J | 1 | 1 |  | JOHN H | 08-050 | 09-017 | 09-032 | 09-032 | 10-027 | 10-064 | 11-003 | 11-051 | 10-023 | 11-012 | 12-018F |  | 10-066 |
| 1312406010 |  | Transfer to CM #6 Assy | 1d | 2011-11-21 | 2011-11-21 | 131302004 FS+5d, 1312406000, 1317010 | 50d | 0d |  |  | HOGAN J | 1 | 1 |  | JOHN H | 08-050 | 09-017 | 09-032 | 09-032 | 10-027 | 10-064 | 11-003 | 11-051 | 10-023 | 11-012 | 12-018F |  | 10-066 |
|  | 07 | **1.3.1.2.4.07 CAVITY STRING ASSEMBLY #7** |  | 2011-11-30 | 2011-12-14 |  |  |  |  |  |  |  |  |  |  |  |  |  |  |  |  |  |  |  |  |  |  |  |
| 1312407000 |  | Cavity String Assy #7 | 10d | 2011-11-30 | 2011-12-13 | 1312107045, 1312107040, 1312107065, 1312107035, 131138050, 1312406010 FS+4d, 1311132055, 1312107050, 1312107055, 1312107060, 1311132060, 1312107030, 131302005 FS-40d | 50d | 0d | SUPPLIES & MATERIALS; SR STAFF [20 h]; MECH DES [40 h]; ELEC ENG [200 h]; MECH ENG [40 h]; SCIENTIST [64 h]; ELEC TECH [40 h]; MECH TECH [800 h] | 80,489.93 | HOGAN J | 1 | 1 |  | JOHN H | 08-050 | 09-017 |  |  | 10-027 | 10-064 | 11-003 | 11-051 |  | 11-012 | 12-018F |  | 10-066 |
| 1312407010 |  | Transfer to CM #7 Assy | 1d | 2011-12-14 | 2011-12-14 | 1312407000, 131302005 FS-40d | 50d | 0d |  |  | HOGAN J | 1 | 1 |  | JOHN H | 08-050 | 09-017 |  |  | 10-027 | 10-064 |  | 11-051 |  | 11-012 | 12-018F |  | 10-066 |

| ID | WBS | Activity | Duration | Start | Finish | Predecessors | Total float | Free float | Resources | Cost | RESP - Responsibility | STRT%COMP for CM EVM | FNSH%COMP for CM EVM | CAM RESPONSIBLE | CR 08-050 | CR 09-017 | CR 09-032 | CR 09-032 Repair | CR 10-023 | CR 10-027 | CR 10-064 | CR 10-066 | CR 11-003 | CR 11-012 | CR 11-051 | CR 12-018 | CR 08-016 | CR 09-012 | CR 12-028 | CR 12-053 | CR 13-003 | CR 13-014 | ReBaseline Actuals Adjustment |
| --- | --- | --- | --- | --- | --- | --- | --- | --- | --- | --- | --- | --- | --- | --- | --- | --- | --- | --- | --- | --- | --- | --- | --- | --- | --- | --- | --- | --- | --- | --- | --- | --- | --- |
|  | 08 | **1.3.1.2.4.08 CAVITY STRING ASSEMBLY #8** |  | 2011-12-21 | 2012-01-12 |  |  |  |  |  |  |  |  |  |  |  |  |  |  |  |  |  |  |  |  |  |  |  |  |  |  |  |  |
| 1312408000 |  | Cavity String Assy #8 | 10d | 2011-12-21 | 2012-01-11 | 1312407010 FS+4d, 1311132065, 1312108035, 1312108040, 1312108060, 1312108030, 1312108045, 1312108055, 1312108065, 1312108050, 131302006 FS-65d, 1311132070 | 50d | 0d | MECH ENG [40 h]; SCIENTIST [64 h]; MECH TECH [800 h]; MECH DES [40 h]; ELEC ENG [200 h]; ELEC TECH [40 h]; SUPPLIES & MATERIALS; SR STAFF [20 h] | 80,489.93 | HOGAN J | 1 | 1 | JOHN H | 08-050 | 09-017 | 09-032 | 09-032 | 10-023 | 10-027 | 10-064 | 10-066 | 11-003 | 11-012 | 11-051 | 12-018F |  |  |  |  |  |  |  |
| 1312408010 |  | Transfer to CM #8 Assy | 1d | 2012-01-12 | 2012-01-12 | 1312408000, 131302006 FS-65d | 50d | 0d |  |  | HOGAN J | 1 | 1 | JOHN H | 08-050 | 09-017 | 09-032 | 09-032 | 10-023 | 10-027 | 10-064 | 10-066 | 11-003 | 11-012 | 11-051 | 12-018F |  |  |  |  |  |  |  |
|  | 09 | **1.3.1.2.4.09 CAVITY STRING ASSEMBLY #9** |  | 2012-01-20 | 2012-02-03 |  |  |  |  |  |  |  |  |  |  |  |  |  |  |  |  |  |  |  |  |  |  |  |  |  |  |  |  |
| 1312409000 |  | Cavity String Assy #9 | 10d | 2012-01-20 | 2012-02-02 | 1311132075, 1312109065, 1312109035, 1312109030, 1312109050, 1311132080, 1312109040, 1312109055, 1312109060, 1312408010 FS+4d, 1312109045 | 50d | 0d | ELEC TECH [40 h]; MECH ENG [40 h]; SR STAFF [20 h]; ELEC ENG [200 h]; SCIENTIST [64 h]; SUPPLIES & MATERIALS; MECH TECH [800 h]; MECH DES [40 h] | 80,489.93 | HOGAN J | 1 | 1 | JOHN H | 08-050 | 09-017 |  |  |  | 10-027 | 10-064 | 10-066 | 11-003 | 11-012 | 11-051 | 12-018F |  |  |  |  |  |  |  |
| 1312409010 |  | Transfer to CM #9 Assy | 1d | 2012-02-03 | 2012-02-03 | 1312409000 | 50d | 0d |  |  | HOGAN J | 1 | 1 | JOHN H | 08-050 | 09-017 |  |  |  | 10-027 | 10-064 | 10-066 | 11-003 | 11-012 | 11-051 | 12-018F |  |  |  |  |  |  |  |
|  | 10 | **1.3.1.2.4.10 CAVITY STRING ASSEMBLY #10** |  | 2012-02-06 | 2012-02-21 |  |  |  |  |  |  |  |  |  |  |  |  |  |  |  |  |  |  |  |  |  |  |  |  |  |  |  |  |
| 1312410000 |  | Cavity String Assy #10 | 10d | 2012-02-06 | 2012-02-17 | 1312409010, 1312110055, 1312110030, 1312110065, 1311132085, 1312110060, 1312110040, 1312110050, 1311132100M, 1312110045, 1312110035, 1311122105M, 1311132090 | 50d | 0d | ELEC TECH [40 h]; MECH TECH [800 h]; MECH DES [40 h]; MECH ENG [40 h]; SCIENTIST [64 h]; SR STAFF [20 h]; SUPPLIES & MATERIALS; ELEC ENG [200 h] | 80,489.93 | HOGAN J | 1 | 1 | JOHN H | 08-050 | 09-017 | 09-032 | 09-032 | 10-023 | 10-027 | 10-064 |  | 11-003 | 11-012 | 11-051 | 12-018F |  |  |  |  |  |  |  |
| 1312410010 |  | Transfer to CM #10 Assy | 1d | 2012-02-21 | 2012-02-21 | 1312410000, 131138055 | 50d |  |  |  | HOGAN J | 1 | 1 | JOHN H | 08-050 | 09-017 | 09-032 | 09-032 | 10-023 | 10-027 |  |  |  |  | 11-051 | 12-018F |  |  |  |  |  |  |  |
|  | 3 | **1.3.1.3 CRYOMODULE ASSEMBLY** |  | 2010-11-16 | 2013-08-30 |  |  |  |  |  |  |  |  |  |  |  |  |  |  |  |  |  |  |  |  |  |  |  |  |  |  |  |  |
|  | 01 | **1.3.1.3.01 SPACE FRAME ASSEMBLY** |  | 2010-11-16 | 2013-08-30 |  |  |  |  |  |  |  |  |  |  |  |  |  |  |  |  |  |  |  |  |  |  |  |  |  |  |  |  |
| 131301001 |  | Space Frame Assy #1 | 40d | 2010-11-16 | 2011-01-21 | 1312401010, 131133020 FS-15d, 131134015, 131121020 FS-20d, 131131020, 131123020 FS-15d, 13114020a, 13114015, 131122017 FS-15d, 131132020 FS-20d, 131122020 FS-15d | 72d | 0d | ELEC ENG [80 h]; SR STAFF [80 h]; ELEC TECH [320 h]; MECH DES [160 h]; SCIENTIST [80 h]; SUPPLIES & MATERIALS; COMP SCIENT [80 h]; MECH ENG [160 h]; MECH TECH [1600 h] | 136,051 | HOGAN J | 1 | 1 | JOHN H | 08-050 | 09-017 | 09-032 | 09-032 |  | 10-027 | 10-064 |  | 11-003 |  | 11-051 | 12-018F | 08-016 | 09-012 |  |  |  |  |  |
| 131301002 |  | Space Frame Assy #2 | 35d | 2011-03-08 | 2011-04-25 | 131132020 FS-12.5d, 131122020 FS-10d, 131121021 FS-12.5d, 1312402010, 131123020 FS-10d, 131133025, 131122025 FS-10d, 131122017 FS-10d | 37d | 0d | ELEC TECH [320 h]; SUPPLIES & MATERIALS; MECH DES [80 h]; MECH ENG [80 h]; MECH TECH [1600 h]; SCIENTIST [40 h]; SR STAFF [40 h]; ELEC ENG [40 h] | 111,940.6 | HOGAN J | 1 | 1 | JOHN H | 08-050 | 09-017 | 09-032 | 09-032 | 10-023 | 10-027 | 10-064 |  | 11-003 | 11-012 | 11-051 |  |  |  |  |  |  |  |  |
| 131301003 |  | Space Frame Assy #3 | 30d | 2011-04-06 | 2011-05-17 | 131123020, 131122025, 131133030, 131121022, 1312403010, 131132020, 131122030, 131302001 | 114d | 0d | MECH DES [40 h]; MECH ENG [40 h]; MECH TECH [1600 h]; SUPPLIES & MATERIALS; SCIENTIST [20 h]; SR STAFF [20 h]; ELEC ENG [40 h]; ELEC TECH [320 h] | 103,796.6 | HOGAN J | 1 | 1 | JOHN H | 08-050 | 09-017 | 09-032 | 09-032 |  | 10-027 | 10-064 |  | 11-003 | 11-012 | 11-051 | 12-018F |  |  | 12-028F |  |  |  |  |
| 131301004 |  | Space Frame Assy #4 | 30d | 2011-06-15 | 2011-07-27 | 1312404010, 131123016c, 131123016d, 131122030 FS-15d, 131123016b, 131122035 FS-15d, 131302002, 131123025 FS-15d, 131132025 FS-25d, 131133035, 131121025 FS-25d | 81d | 46d | ELEC ENG [16 h]; ELEC TECH [240 h]; MECH DES [4 h]; MECH ENG [40 h]; MECH TECH [1600 h]; SCIENTIST [4 h]; SR STAFF [4 h]; SUPPLIES & MATERIALS | 94,206.36 | HOGAN J | 1 | 1 | JOHN H | 08-050 | 09-017 | 09-032 | 09-032 | 10-023 | 10-027 | 10-064 | 10-066 |  | 11-012 | 11-051 | 12-018F |  |  | 12-028F |  |  |  |  |
| 131301005 |  | Space Frame Assy #5 | 30d | 2011-06-30 | 2011-08-11 | 131132025 FS-20d, 131121026 FS-20d, 131122040 FS-10d, 131302003, 131134016, 131122035 FS-10d, 131133040, 131131021b, 131123025 FS-10d, 1312405010, 131134018 | 130d | 86d | SUPPLIES & MATERIALS; MECH DES [4 h]; MECH ENG [40 h]; SCIENTIST [4 h]; MECH TECH [1600 h]; ELEC ENG [16 h]; SR STAFF [4 h]; ELEC TECH [240 h] | 94,206.36 | HOGAN J | 1 | 1 | JOHN H | 08-050 | 09-017 |  |  |  | 10-027 | 10-064 | 10-066 |  | 11-012 | 11-051 | 12-018F |  |  | 12-028F |  |  |  |  |
| 131301006 |  | Space Frame Assy #6 | 40d | 2011-11-22 | 2012-01-27 | 131123025 FS-5d, 1312406010, 131121027 FS-10d, 131122040 FS-5d, 131132025 FS-10d, 131133045, 131302004, 131122045 FS-5d, 131301005 FS-15d | 92d | 0d | MECH DES [4 h]; MECH ENG [40 h]; SCIENTIST [4 h]; ELEC ENG [16 h]; ELEC TECH [240 h]; SR STAFF [4 h]; MECH TECH [1600 h]; SUPPLIES & MATERIALS | 97,204.26 | HOGAN J | 1 | 1 | JOHN H | 08-050 | 09-017 | 09-032 | 09-032 | 10-023 | 10-027 | 10-064 | 10-066 | 11-003 | 11-012 | 11-051 | 12-018F |  |  |  |  |  |  |  |
| 131301006a |  | Space Frame Assy #6 Reverse entry | 1d | 2012-02-01 | 2012-02-01 | 9-120M FS+78d | 153d | 0d | SCIENTIST [-4 h]; ELEC ENG [-16 h]; ELEC TECH [-240 h]; SR STAFF [-4 h]; MECH TECH [-1600 h]; SUPPLIES & MATERIALS; MECH DES [-4 h]; MECH ENG [-40 h] | -97,204.26 | HOGAN J | 1 | 1 | JOHN H | 08-050 | 09-017 | 09-032 | 09-032 | 10-023 | 10-027 | 10-064 | 10-066 | 11-003 | 11-012 | 11-051 | 12-018 |  |  | 12-028F |  |  |  |  |
| 131301007 |  | Space Frame Assy #7 | 24d | 2012-02-03 | 2012-03-08 | 131133050, 131132025, 131121028, 131122045, 131122050, 131123025, 131302005, 1312407010 | 162d | 0d | MECH TECH [1600 h]; ELEC ENG [16 h]; SUPPLIES & MATERIALS; MECH DES [4 h]; SR STAFF [4 h]; MECH ENG [40 h]; ELEC TECH [240 h]; SCIENTIST [4 h] | 97,204.26 | HOGAN J | 1 | 1 | JOHN H | 08-050 | 09-017 |  |  |  | 10-027 | 10-064 | 10-066 |  | 11-012 | 11-051 | 12-018 |  |  | 12-028F |  |  |  |  |
| 131301006b |  | Space Frame Assy #6 | 30d | 2012-02-27 | 2012-04-06 | 131122045 FS-5d, 131301006a FS+16d, 131122040 FS-5d, 131123025 FS-5d, 131132025 FS-10d, 131133045, 131301005 FS-15d, 1312406010, 131121027 FS-10d, 131302004 | 153d | 35d | MECH DES [4 h]; MECH ENG [40 h]; SCIENTIST [4 h]; ELEC ENG [16 h]; MECH TECH [1600 h]; SUPPLIES & MATERIALS; ELEC TECH [240 h]; SR STAFF [4 h] | 97,204.26 | HOGAN J | 1 | 1 | JOHN H | 08-050 | 09-017 | 09-032 | 09-032 | 10-023 | 10-027 | 10-064 | 10-066 | 11-003 | 11-012 | 11-051 | 12-018 |  |  | 12-028F |  |  |  |  |
| 131301008 |  | Space Frame Assy #8 | 33d | 2012-05-29 | 2012-07-13 | 131122055 FS-20d, 1312408010, 131123030 FS-20d, 131132030 FS-20d, 131132030a, 131302007, 131122050 FS-20d, 131121029, 1317025, 131133055 | 141d | 0d | MECH DES [4 h]; MECH ENG [40 h]; SCIENTIST [4 h]; ELEC ENG [16 h]; ELEC TECH [240 h]; SR STAFF [4 h]; MECH TECH [1600 h]; SUPPLIES & MATERIALS | 97,204.26 | HOGAN J | 1 | 1 | JOHN H | 08-050 | 09-017 | 09-032 | 09-032 | 10-023 | 10-027 | 10-064 | 10-066 | 11-003 | 11-012 | 11-051 | 12-018 |  |  | 12-028F |  |  |  |  |
| 131301009 |  | Space Frame Assy #9 | 44d | 2012-07-09 | 2012-09-07 | 131121030 FS-12.5d, 1312409010, 131302006b, 131133060, 131122060 FS-10d, 131122055 FS-10d, 131132030 FS-12.5d, 131132030a, 131123030 FS-10d | 146d | 0d | MECH DES [4 h]; MECH ENG [40 h]; SR STAFF [4 h]; SCIENTIST [4 h]; ELEC ENG [16 h]; SUPPLIES & MATERIALS; ELEC TECH [240 h]; MECH TECH [1600 h] | 97,204.26 | HOGAN J | 1 | 1 | JOHN H | 08-050 | 09-017 |  |  |  | 10-027 | 10-064 | 10-066 |  | 11-012 | 11-051 | 12-018 |  |  | 12-028F |  |  |  |  |
| 131301010 |  | Space Frame Assy #10 FY12 | 19d | 2012-09-04 | 2012-09-28 | 131123030, 131132030a, 131122060, 131132030, 131133065, 131121045LOE, 131302008, 1312410010, 131121010CLOE, 131121035 | 141d | 0d | ELEC ENG [7.79 h]; ELEC TECH [116.92 h]; SUPPLIES & MATERIALS; MECH ENG [19.49 h]; MECH TECH [779.49 h]; SCIENTIST [1.95 h]; MECH DES [1.95 h]; SR STAFF [1.95 h] | 47,356.06 | HOGAN J | 1 | 1 | JOHN H | 08-050 | 09-017 | 09-032 | 09-032 | 10-023 | 10-027 | 10-064 | 10-066 | 11-003 | 11-012 | 11-051 | 12-018 |  |  | 12-028F | 12-053 |  |  |  |
| 131301010a |  | Space Frame Assy #10 FY13 | 20d | 2012-10-01 | 2012-10-26 | 131301010 | 141d | 0d | MECH ENG [30.48 h]; MECH TECH [1219.28 h]; SCIENTIST [3.05 h]; MECH DES [3.05 h]; SR STAFF [3.05 h]; ELEC ENG [12.2 h]; ELEC TECH [182.9 h]; SUPPLIES & MATERIALS | 76,442.03 | HOGAN J | 1 | 1 | JOHN H | 08-050 | 09-017 | 09-032 | 09-032 | 10-023 | 10-027 | 10-064 | 10-066 | 11-003 | 11-012 | 11-051 | 12-018 |  |  | 12-028F | 12-053 | 13-003 |  |  |
| 131301015 |  | Re-Baseline Actuals Adjustment | 1d | 2013-08-30 | 2013-08-30 | 9-130M FS+227d | 20d |  | PROCUREMENT>$50K 69 NO ESCALATION | -122,565.21 | HOGAN J | 1 | 1 | JOHN H |  |  |  |  |  |  |  |  |  |  |  |  |  |  |  |  |  | 13-014 | ADJ |

Notes:
- 131301001: Corrective Actions: Modified lags to move start date of / construction

| ID | WBS | Activity | Duration | Start | Finish | Predecessors | Total float | Free float | Resources | Cost | RESP - Responsibility | STRT%COMP for CM EVM | FNSH%COMP for CM EVM | CR 08-016 | CAM RESPONSIBLE | CR 08-050 | CR 09-012 | CR 09-017 | CR 09-032 | CR 09-032 Repair | CR 10-027 | CR 10-064 | CR 11-003 | CR 11-051 | CR 12-018 | CR 10-023 | CR 11-012 | CR 12-028 | CR 10-066 | CR 12-053 | CR 13-003 | CR 13-014 | ReBaseline Actuals Adjustment |
| --- | --- | --- | --- | --- | --- | --- | --- | --- | --- | --- | --- | --- | --- | --- | --- | --- | --- | --- | --- | --- | --- | --- | --- | --- | --- | --- | --- | --- | --- | --- | --- | --- | --- |
|  | 02 | **1.3.1.3.02 CRYOMODULE ASSEMBLY** |  | 2011-01-24 | 2013-08-30 |  |  |  |  |  |  |  |  |  |  |  |  |  |  |  |  |  |  |  |  |  |  |  |  |  |  |  |  |
| 131302001 |  | Cryomodule Assy #1 | 40d | 2011-01-24 | 2011-03-21 | 131137040, 131131020, 131122017 FS-15d, 131136020 FS-15d, 131139025, 131133070, 131123020 FS-15d, 131138020 FS-15d, 131132020 FS-20d, 13114020a, 131137015, 131137030, 131135020a, 13115015, 131138030, 131122075, 131137050, 131138040, 131301001, 13114015, 131134015, 131122020 FS-15d | 72d | 0d | ELEC TECH [320 h]; SCIENTIST [80 h]; COMP SCIENT [80 h]; MECH ENG [160 h]; MECH TECH [1600 h]; ELEC ENG [80 h]; SR STAFF [80 h]; SUPPLIES & MATERIALS; MECH DES [160 h] | 136,051 | HOGAN J | 1 | 1 | 08-016 | JOHN H | 08-050 | 09-012 | 09-017 | 09-032 | 09-032 | 10-027 | 10-064 | 11-003 | 11-051 | 12-018F |  |  |  |  |  |  |  |  |
| 131302002 |  | Cryomodule Assy #2 | 35d | 2011-04-26 | 2011-06-14 | 131136025, 131122080, 131132020 FS-12.5d, 131122017 FS-10d, 131302001 FS-15d, 131122025 FS-10d, 131122020 FS-10d, 131133075, 131138020 FS-10d, 131123020 FS-10d, 131301002, 131135025 | 37d | 0d | SR STAFF [40 h]; ELEC ENG [40 h]; ELEC TECH [320 h]; MECH DES [80 h]; MECH ENG [80 h]; MECH TECH [1600 h]; SUPPLIES & MATERIALS; SCIENTIST [40 h] | 111,940.6 | HOGAN J | 1 | 1 |  | JOHN H | 08-050 |  | 09-017 | 09-032 | 09-032 | 10-027 | 10-064 | 11-003 | 11-051 |  | 10-023 | 11-012 |  |  |  |  |  |  |
| 131302003 |  | Cryomodule Assy #3 | 30d | 2011-05-18 | 2011-06-29 | 131138020, 131135030, 131122030, 131136030, 131122085, 131301003, 131133080, 131122025, 131132020, 131123020 | 114d | 0d | SR STAFF [20 h]; ELEC ENG [40 h]; ELEC TECH [320 h]; MECH DES [40 h]; MECH ENG [40 h]; SUPPLIES & MATERIALS; MECH TECH [1600 h]; SCIENTIST [20 h] | 103,796.6 | HOGAN J | 1 | 1 |  | JOHN H | 08-050 |  | 09-017 | 09-032 | 09-032 | 10-027 | 10-064 | 11-003 | 11-051 | 12-018F |  | 11-012 | 12-028F |  |  |  |  |  |
| 131302004 |  | Cryomodule Assy #4 | 30d | 2011-10-03 | 2011-11-11 | 131133085, 131123025 FS-15d, 131132025 FS-25d, 131122035 FS-15d, 131122030 FS-15d, 9-120M, 131301004, 131138020, 131122090, 131135035, 131136035 | 35d | 0d | SCIENTIST [4 h]; SR STAFF [4 h]; ELEC TECH [240 h]; MECH DES [4 h]; MECH ENG [40 h]; MECH TECH [1600 h]; SUPPLIES & MATERIALS; ELEC ENG [16 h] | 97,204.26 | HOGAN J | 1 | 1 |  | JOHN H | 08-050 |  | 09-017 | 09-032 | 09-032 | 10-027 | 10-064 |  | 11-051 | 12-018F | 10-023 | 11-012 | 12-028F | 10-066 |  |  |  |  |
| 131302005 |  | Cryomodule Assy #5 | 20d | 2012-01-05 | 2012-02-02 | 131138020ba, 131135040, 131131021b, 131132025 FS-20d, 131122095, 9-120M FS+60d, 131134018, 131123025 FS-10d, 131301005, 131134016, 131136040, 131134021LOE, 131133090, 131122035 FS-10d, 131122040 FS-10d | 35d | 0d | ELEC TECH [240 h]; ELEC ENG [16 h]; SR STAFF [4 h]; MECH TECH [1600 h]; SUPPLIES & MATERIALS; MECH DES [4 h]; MECH ENG [40 h]; SCIENTIST [4 h] | 97,204.26 | HOGAN J | 1 | 1 |  | JOHN H | 08-050 |  | 09-017 |  |  | 10-027 | 10-064 |  | 11-051 | 12-018F |  | 11-012 | 12-028F | 10-066 |  |  |  |  |
| 131302006 |  | Cryomodule Assy #6 | 2d | 2012-01-30 | 2012-01-31 | 131136045, 131122045 FS-5d, 131122040 FS-5d, 131138020ba, 131133095, 131123025 FS-5d, 131132025 FS-10d, 131301006, 131122100, 131135045 | 92d | 42d | SUPPLIES & MATERIALS; MECH DES [0.4 h]; MECH ENG [4 h]; SCIENTIST [0.4 h]; ELEC ENG [1.6 h]; ELEC TECH [24 h]; SR STAFF [0.4 h]; MECH TECH [160 h] | 9,720.43 | HOGAN J | 1 | 1 |  | JOHN H | 08-050 |  | 09-017 | 09-032 | 09-032 | 10-027 | 10-064 | 11-003 | 11-051 | 12-018 | 10-023 | 11-012 |  | 10-066 |  |  |  |  |
| 131302006a |  | Cryomodule Assy #6 Reverse Entry | 1d | 2012-02-01 | 2012-02-01 | 9-120M FS+78d | 199d | 81d | SUPPLIES & MATERIALS; MECH DES [-0.4 h]; MECH ENG [-4 h]; SCIENTIST [-0.4 h]; ELEC ENG [-1.6 h]; ELEC TECH [-24 h]; SR STAFF [-0.4 h]; MECH TECH [-160 h] | -9,720.43 | HOGAN J | 1 | 1 |  | JOHN H | 08-050 |  | 09-017 | 09-032 | 09-032 | 10-027 | 10-064 | 11-003 | 11-051 | 12-018 | 10-023 | 11-012 | 12-028F | 10-066 |  |  |  |  |
| 131302007 |  | Cryomodule Assy #7 | 35d | 2012-03-09 | 2012-04-26 | 131122050, 131301007, 131132025, 131138020d, 131122045, 131122105, 131123025, 131133100, 131135050, 131136050 | 162d | 21d | ELEC ENG [16 h]; SUPPLIES & MATERIALS; MECH DES [4 h]; SCIENTIST [4 h]; SR STAFF [4 h]; MECH ENG [40 h]; ELEC TECH [240 h]; MECH TECH [1600 h] | 97,204.26 | HOGAN J | 1 | 1 |  | JOHN H | 08-050 |  | 09-017 |  |  | 10-027 | 10-064 |  | 11-051 | 12-018 |  | 11-012 | 12-028F | 10-066 |  |  |  |  |
| 131302006b |  | Cryomodule Assy #6 | 28d | 2012-05-29 | 2012-07-06 | 131302006a, 131132025 FS-10d, 131301006, 131122100, 131135045, 131122045 FS-5d, 131138020ba, 131136045, 131123025 FS-5d, 131301006b, 1317025, 131133095, 131122040 FS-5d | 118d | 0d | SUPPLIES & MATERIALS; MECH DES [4 h]; MECH ENG [40 h]; SCIENTIST [4 h]; ELEC ENG [16 h]; ELEC TECH [240 h]; SR STAFF [4 h]; MECH TECH [1600 h] | 97,204.26 | HOGAN J | 1 | 1 |  | JOHN H | 08-050 |  | 09-017 | 09-032 | 09-032 | 10-027 | 10-064 | 11-003 | 11-051 | 12-018 | 10-023 | 11-012 | 12-028F | 10-066 |  |  |  |  |
| 131302008 |  | Cryomodule Assy #8 | 35d | 2012-07-16 | 2012-08-31 | 131122050 FS-20d, 131138030 FS-20d, 131301008, 131135055, 131122110, 131123030 FS-20d, 131132030a, 131132030 FS-20d, 131138020d, 131136055, 131133105, 131122055 FS-20d | 141d | 0d | ELEC TECH [240 h]; SR STAFF [4 h]; ELEC ENG [16 h]; MECH TECH [1600 h]; SUPPLIES & MATERIALS; MECH DES [4 h]; MECH ENG [40 h]; SCIENTIST [4 h] | 97,204.26 | HOGAN J | 1 | 1 |  | JOHN H | 08-050 |  | 09-017 | 09-032 | 09-032 | 10-027 | 10-064 | 11-003 | 11-051 | 12-018 | 10-023 | 11-012 | 12-028F | 10-066 |  |  |  |  |
| 131302009 |  | Cryomodule Assy #9 FY12 | 15d | 2012-09-10 | 2012-09-28 | 131122055 FS-10d, 131122060 FS-10d, 131123030 FS-10d, 131301009, 131133110, 131138030 FS-10d, 131138020g, 131132030a, 131135060, 131136060, 131132030 FS-12.5d | 146d | 0d | SUPPLIES & MATERIALS; ELEC TECH [120 h]; MECH TECH [800 h]; MECH DES [2 h]; MECH ENG [20 h]; SCIENTIST [2 h]; SR STAFF [2 h]; ELEC ENG [8 h] | 48,602.13 | HOGAN J | 1 | 1 |  | JOHN H | 08-050 |  | 09-017 |  |  | 10-027 | 10-064 |  | 11-051 | 12-018 |  | 11-012 | 12-028F | 10-066 | 12-053 |  |  |  |
| 131302009a |  | Cryomodule Assy #9 FY13 | 15d | 2012-10-01 | 2012-10-19 | 131302009 | 146d | 33d | SCIENTIST [3 h]; SR STAFF [3 h]; ELEC ENG [11.99 h]; SUPPLIES & MATERIALS; ELEC TECH [179.81 h]; MECH TECH [1198.77 h]; MECH DES [3 h]; MECH ENG [29.97 h] | 75,155.69 | HOGAN J | 1 | 1 |  | JOHN H | 08-050 |  | 09-017 |  |  | 10-027 | 10-064 |  | 11-051 | 12-018 |  | 11-012 | 12-028F | 10-066 | 12-053 | 13-003 |  |  |
| 131302010 |  | Cryomodule Assy #10 | 28d | 2012-10-29 | 2012-12-07 | 131138065LOE, 131138020g, 131135065, 131132030a, 131122060, 131132030, 131123030, 131133130LOE, 131133115a, 131122065R, 131301010a, 131138030, 131136065 | 141d | 28d | ELEC ENG [23.98 h]; ELEC TECH [359.63 h]; SUPPLIES & MATERIALS; MECH ENG [59.94 h]; MECH TECH [2397.53 h]; SCIENTIST [5.99 h]; MECH DES [5.99 h]; SR STAFF [5.99 h] | 150,308.98 | HOGAN J | 1 | 1 |  | JOHN H | 08-050 |  | 09-017 | 09-032 | 09-032 | 10-027 | 10-064 | 11-003 | 11-051 | 12-018 | 10-023 | 11-012 | 12-028F | 10-066 |  | 13-003 |  |  |
| 131302015 |  | Re-Baseline Actuals Adjustment | 1d | 2013-08-30 | 2013-08-30 | 9-130M FS+227d | 20d |  | PROCUREMENT>$50K 69 NO ESCALATION | 59,440.84 | HOGAN J | 1 | 1 |  | JOHN H |  |  |  |  |  |  |  |  |  |  |  |  |  |  |  |  | 13-014 | ADJ |
|  | 03 | **1.3.1.3.03 N/A** |  |  |  |  |  |  |  |  |  |  |  |  |  |  |  |  |  |  |  |  |  |  |  |  |  |  |  |  |  |  |  |
|  | 04 | **1.3.1.3.04 N/A** |  |  |  |  |  |  |  |  |  |  |  |  |  |  |  |  |  |  |  |  |  |  |  |  |  |  |  |  |  |  |  |
|  | 05 | **1.3.1.3.05 N/A** |  |  |  |  |  |  |  |  |  |  |  |  |  |  |  |  |  |  |  |  |  |  |  |  |  |  |  |  |  |  |  |
|  | 06 | **1.3.1.3.06 N/A** |  |  |  |  |  |  |  |  |  |  |  |  |  |  |  |  |  |  |  |  |  |  |  |  |  |  |  |  |  |  |  |
|  | 07 | **1.3.1.3.07 N/A** |  |  |  |  |  |  |  |  |  |  |  |  |  |  |  |  |  |  |  |  |  |  |  |  |  |  |  |  |  |  |  |
|  | 08 | **1.3.1.3.08 N/A** |  |  |  |  |  |  |  |  |  |  |  |  |  |  |  |  |  |  |  |  |  |  |  |  |  |  |  |  |  |  |  |
|  | 09 | **1.3.1.3.09 N/A** |  |  |  |  |  |  |  |  |  |  |  |  |  |  |  |  |  |  |  |  |  |  |  |  |  |  |  |  |  |  |  |
|  | 10 | **1.3.1.3.10 N/A** |  |  |  |  |  |  |  |  |  |  |  |  |  |  |  |  |  |  |  |  |  |  |  |  |  |  |  |  |  |  |  |
|  | 1 | **(New WBS)** |  |  |  |  |  |  |  |  |  |  |  |  |  |  |  |  |  |  |  |  |  |  |  |  |  |  |  |  |  |  |  |
|  | 4 | **1.3.1.4 CRYOMODULE ACCEPTANCE TEST** |  | 2011-03-22 | 2013-08-30 |  |  |  |  |  |  |  |  |  |  |  |  |  |  |  |  |  |  |  |  |  |  |  |  |  |  |  |  |
| 1314000 |  | Re-Baseline Actuals Adjustment | 1d | 2013-08-30 | 2013-08-30 | 9-130M FS+227d | 20d |  | PROCUREMENT>$50K 69 NO ESCALATION | -5,229.75 | HOGAN J | 1 | 1 |  | JOHN H |  |  |  |  |  |  |  |  |  |  |  |  |  |  |  |  | 13-014 | ADJ |

Notes:
- 131302001: Corrective Actions: Modified lags to move start date of / construction

| ID | WBS | Activity | Duration | Start | Finish | Predecessors | Total float | Free float | Resources | Cost | RESP - Responsibility | STRT%COMP for CM EVM | FNSH%COMP for CM EVM | CAM RESPONSIBLE | CR 08-050 | CR 09-017 | CR 09-032 | CR 09-032 Repair | CR 10-031 | CR 10-064 | CR 10-065 | CR 10-066 | CR 11-012 | CR 11-051 | CR 12-018 | CR 12-028 | CR 10-023 | CR 11-003 | CR 12-053 | CR 13-003 | CR 10-027 | CR 13-014 | ReBaseline Actuals Adjustment |
| --- | --- | --- | --- | --- | --- | --- | --- | --- | --- | --- | --- | --- | --- | --- | --- | --- | --- | --- | --- | --- | --- | --- | --- | --- | --- | --- | --- | --- | --- | --- | --- | --- | --- |
|  | 01 | **1.3.1.4.01 CRYOMODULE ACCEPTANCE TEST #1** |  | 2011-03-22 | 2011-04-25 |  |  |  |  |  |  |  |  |  |  |  |  |  |  |  |  |  |  |  |  |  |  |  |  |  |  |  |  |
| 131401000 |  | Acceptance Test Cryomodule #1 | 25d | 2011-03-22 | 2011-04-25 | 131116025, 131302001 | 72d | 19d | ELEC ENG [240 h]; MECH TECH [200 h]; SUPPLIES & MATERIALS; COMP SCIENT [80 h]; SCIENTIST [200 h]; SR STAFF [200 h]; ELEC TECH [120 h]; MECH ENG [120 h] | 84,146.3 | HOGAN J | 1 | 1 | JOHN H | 08-050 | 09-017 | 09-032 | 09-032 | 10-031 | 10-064 | 10-065 | 10-066 |  |  |  |  |  |  |  |  |  |  |  |
|  | 02 | **1.3.1.4.02 CRYOMODULE ACCEPTANCE TEST #2** |  | 2011-06-15 | 2011-07-20 |  |  |  |  |  |  |  |  |  |  |  |  |  |  |  |  |  |  |  |  |  |  |  |  |  |  |  |  |
| 131402000 |  | Acceptance Test Cryomodule #2 | 25d | 2011-06-15 | 2011-07-20 | 131302002, 131401000 | 37d | 0d | SCIENTIST [120 h]; ELEC ENG [240 h]; SR STAFF [120 h]; COMP SCIENT [60 h]; MECH ENG [80 h]; ELEC TECH [120 h]; MECH TECH [160 h]; SUPPLIES & MATERIALS | 64,198.5 | HOGAN J | 1 | 1 | JOHN H | 08-050 | 09-017 | 09-032 | 09-032 | 10-031 | 10-064 | 10-065 | 10-066 | 11-012 |  |  |  |  |  |  |  |  |  |  |
|  | 03 | **1.3.1.4.03 CRYOMODULE ACCEPTANCE TEST #3** |  | 2011-11-01 | 2011-12-07 |  |  |  |  |  |  |  |  |  |  |  |  |  |  |  |  |  |  |  |  |  |  |  |  |  |  |  |  |
| 131403000 |  | Acceptance Test Cryomodule #3 | 25d | 2011-11-01 | 2011-12-07 | 131302003, 9-120M FS+21d, 131402000 | 49d | 0d | ELEC TECH [120 h]; COMP SCIENT [40 h]; MECH ENG [80 h]; MECH TECH [160 h]; SUPPLIES & MATERIALS; SCIENTIST [40 h]; SR STAFF [40 h]; ELEC ENG [240 h] | 50,243.29 | HOGAN J | 1 | 1 | JOHN H | 08-050 | 09-017 | 09-032 | 09-032 | 10-031 | 10-064 |  | 10-066 | 11-012 | 11-051 | 12-018F | 12-028F |  |  |  |  |  |  |  |
|  | 04 | **1.3.1.4.04 CRYOMODULE ACCEPTANCE TEST #4** |  | 2011-12-08 | 2012-03-30 |  |  |  |  |  |  |  |  |  |  |  |  |  |  |  |  |  |  |  |  |  |  |  |  |  |  |  |  |
| 131404000 |  | Acceptance Test Cryomodule #4 | 20d | 2011-12-08 | 2012-01-12 | 131403000, 131302004 | 49d | 14d | ELEC TECH [120 h]; COMP SCIENT [40 h]; MECH ENG [80 h]; MECH TECH [160 h]; SUPPLIES & MATERIALS; SCIENTIST [40 h]; SR STAFF [40 h]; ELEC ENG [240 h] | 50,243.29 | HOGAN J | 1 | 1 | JOHN H | 08-050 | 09-017 | 09-032 | 09-032 | 10-031 | 10-064 |  | 10-066 | 11-012 | 11-051 | 12-018F | 12-028F | 10-023 |  |  |  |  |  |  |
| 131404005 |  | Acceptance Test Cryomodule #4 Reverse Entry | 1d | 2012-02-01 | 2012-02-01 | 9-120M FS+78d | 51d | 16d | SR STAFF [-40 h]; ELEC ENG [-240 h]; ELEC TECH [-120 h]; COMP SCIENT [-40 h]; MECH ENG [-80 h]; MECH TECH [-160 h]; SUPPLIES & MATERIALS; SCIENTIST [-40 h] | -50,243.29 | HOGAN J | 1 | 1 | JOHN H | 08-050 | 09-017 | 09-032 | 09-032 | 10-031 | 10-064 |  | 10-066 | 11-012 | 11-051 | 12-018 | 12-028F | 10-023 |  |  |  |  |  |  |
| 131404010 |  | Acceptance Test Cryomodule #4 | 25d | 2012-02-27 | 2012-03-30 | 131405000 FS+1d, 131404005, 131403000, 131302004 FS+65d | 35d | 0d | SR STAFF [40 h]; ELEC TECH [120 h]; COMP SCIENT [40 h]; MECH ENG [80 h]; MECH TECH [160 h]; ELEC ENG [240 h]; SUPPLIES & MATERIALS; SCIENTIST [40 h] | 50,243.29 | HOGAN J | 1 | 1 | JOHN H | 08-050 | 09-017 | 09-032 | 09-032 | 10-031 | 10-064 |  | 10-066 | 11-012 | 11-051 | 12-018 | 12-028F | 10-023 |  |  |  |  |  |  |
|  | 05 | **1.3.1.4.05 CRYOMODULE ACCEPTANCE TEST #5** |  | 2012-02-03 | 2012-02-23 |  |  |  |  |  |  |  |  |  |  |  |  |  |  |  |  |  |  |  |  |  |  |  |  |  |  |  |  |
| 131405000 |  | Acceptance Test Cryomodule #5 | 14d | 2012-02-03 | 2012-02-23 | 131404000, 131302005 | 35d | 0d | MECH ENG [80 h]; MECH TECH [160 h]; SUPPLIES & MATERIALS; SCIENTIST [40 h]; ELEC ENG [240 h]; SR STAFF [40 h]; ELEC TECH [120 h]; COMP SCIENT [40 h] | 50,243.29 | HOGAN J | 1 | 1 | JOHN H | 08-050 | 09-017 |  |  | 10-031 | 10-064 |  | 10-066 | 11-012 | 11-051 | 12-018 | 12-028F |  |  |  |  |  |  |  |
|  | 06 | **1.3.1.4.06 CRYOMODULE ACCEPTANCE TEST #6** |  | 2012-07-16 | 2012-08-31 |  |  |  |  |  |  |  |  |  |  |  |  |  |  |  |  |  |  |  |  |  |  |  |  |  |  |  |  |
| 131406000 |  | Acceptance Test Cryomodule #6 | 35d | 2012-07-16 | 2012-08-31 | 131404010, 131302006b, 131302006, 1317035 | 113d | 0d | SUPPLIES & MATERIALS; SCIENTIST [40 h]; COMP SCIENT [40 h]; SR STAFF [40 h]; ELEC ENG [240 h]; ELEC TECH [120 h]; MECH ENG [80 h]; MECH TECH [160 h] | 50,243.29 | HOGAN J | 1 | 1 | JOHN H | 08-050 | 09-017 | 09-032 | 09-032 | 10-031 | 10-064 |  | 10-066 | 11-012 | 11-051 | 12-018 | 12-028F | 10-023 | 11-003 |  |  |  |  |  |
|  | 07 | **1.3.1.4.07 CRYOMODULE ACCEPTANCE TEST #7** |  | 2012-09-04 | 2012-10-19 |  |  |  |  |  |  |  |  |  |  |  |  |  |  |  |  |  |  |  |  |  |  |  |  |  |  |  |  |
| 131407000 |  | Acceptance Test Cryomodule #7 FY12 | 19d | 2012-09-04 | 2012-09-28 | 131406000, 131302007 | 113d | 0d | MECH ENG [44.71 h]; SCIENTIST [22.35 h]; SR STAFF [22.35 h]; COMP SCIENT [22.35 h]; ELEC ENG [134.12 h]; ELEC TECH [67.06 h]; MECH TECH [89.41 h]; SUPPLIES & MATERIALS | 28,076.84 | HOGAN J | 1 | 1 | JOHN H | 08-050 | 09-017 |  |  | 10-031 | 10-064 |  | 10-066 | 11-012 | 11-051 | 12-018 | 12-028F |  | 11-003 | 12-053 |  |  |  |  |
| 131407000a |  | Acceptance Test Cryomodule #7 FY13 | 15d | 2012-10-01 | 2012-10-19 | 131407000 | 113d | 0d | MECH ENG [35.29 h]; SCIENTIST [17.65 h]; SR STAFF [17.65 h]; COMP SCIENT [17.65 h]; ELEC ENG [105.88 h]; ELEC TECH [52.94 h]; MECH TECH [70.59 h]; SUPPLIES & MATERIALS | 22,873.69 | HOGAN J | 1 | 1 | JOHN H | 08-050 | 09-017 |  |  | 10-031 | 10-064 |  | 10-066 | 11-012 | 11-051 | 12-018 | 12-028F |  | 11-003 | 12-053 |  |  |  |  |
|  | 08 | **1.3.1.4.08 CRYOMODULE ACCEPTANCE TEST #8** |  | 2012-10-22 | 2012-12-07 |  |  |  |  |  |  |  |  |  |  |  |  |  |  |  |  |  |  |  |  |  |  |  |  |  |  |  |  |
| 131408000 |  | Acceptance Test Cryomodule #8 | 33d | 2012-10-22 | 2012-12-07 | 131302008, 131407000a | 113d | 0d | SR STAFF [52.86 h]; ELEC ENG [317.15 h]; ELEC TECH [158.58 h]; MECH ENG [105.72 h]; SUPPLIES & MATERIALS; SCIENTIST [52.86 h]; MECH TECH [211.43 h]; COMP SCIENT [52.86 h] | 68,513.53 | HOGAN J | 1 | 1 | JOHN H | 08-050 | 09-017 | 09-032 | 09-032 | 10-031 | 10-064 |  | 10-066 | 11-012 | 11-051 | 12-018 | 12-028F | 10-023 | 11-003 |  | 13-003 |  |  |  |
|  | 09 | **1.3.1.4.09 CRYOMODULE ACCEPTANCE TEST #9** |  | 2012-12-10 | 2013-01-25 |  |  |  |  |  |  |  |  |  |  |  |  |  |  |  |  |  |  |  |  |  |  |  |  |  |  |  |  |
| 131409000 |  | Acceptance Test Cryomodule #9 | 28d | 2012-12-10 | 2013-01-25 | 131408000, 131302009a | 113d | 0d | COMP SCIENT [52.86 h]; MECH ENG [105.72 h]; MECH TECH [211.43 h]; SUPPLIES & MATERIALS; SCIENTIST [52.86 h]; ELEC ENG [317.15 h]; ELEC TECH [158.58 h]; SR STAFF [52.86 h] | 68,513.53 | HOGAN J | 1 | 1 | JOHN H | 08-050 | 09-017 |  |  | 10-031 | 10-064 |  | 10-066 | 11-012 | 11-051 | 12-018 | 12-028F |  | 11-003 |  | 13-003 | 10-027 |  |  |
|  | 10 | **1.3.1.4.10 CRYOMODULE ACCEPTANCE TEST #10** |  | 2013-01-28 | 2013-03-15 |  |  |  |  |  |  |  |  |  |  |  |  |  |  |  |  |  |  |  |  |  |  |  |  |  |  |  |  |
| 131410000 |  | Acceptance Test Cryomodule #10 | 34d | 2013-01-28 | 2013-03-15 | 131302010, 131409000 | 113d | 13d | MECH TECH [211.43 h]; SCIENTIST [52.86 h]; SR STAFF [52.86 h]; ELEC TECH [158.58 h]; COMP SCIENT [52.86 h]; ELEC ENG [317.15 h]; MECH ENG [105.72 h]; SUPPLIES & MATERIALS | 68,513.53 | HOGAN J | 1 | 1 | JOHN H | 08-050 | 09-017 | 09-032 | 09-032 | 10-031 | 10-064 |  | 10-066 | 11-012 | 11-051 | 12-018 | 12-028F | 10-023 | 11-003 |  | 13-003 | 10-027 |  |  |
|  | 5 | **1.3.1.5 CRYOMODULE INSTALLATION AND TEST** |  | 2011-05-23 | 2013-08-30 |  |  |  |  |  |  |  |  |  |  |  |  |  |  |  |  |  |  |  |  |  |  |  |  |  |  |  |  |
| 1315000 |  | Re-Baseline Actuals Adjustment | 1d | 2013-08-30 | 2013-08-30 | 9-130M FS+227d | 20d |  | PROCUREMENT>$50K 69 NO ESCALATION | 58,387.38 | HOGAN J | 1 | 1 | JOHN H |  |  |  |  |  |  |  |  |  |  |  |  |  |  |  |  |  | 13-014 | ADJ |

| ID | WBS | Activity | Duration | Start | Finish | Predecessors | Total float | Free float | Resources | Cost | RESP - Responsibility | STRT%COMP for CM EVM | FNSH%COMP for CM EVM | CAM RESPONSIBLE | CR 08-050 | CR 10-031 | CR 10-064 | CR 10-065 | CR 10-066 | CR 11-012 | CR 12-001 | CR 12-018 | CR 12-028 | CR 13-003 |
| --- | --- | --- | --- | --- | --- | --- | --- | --- | --- | --- | --- | --- | --- | --- | --- | --- | --- | --- | --- | --- | --- | --- | --- | --- |
|  | 01 | **1.3.1.5.01 CRYOMODULE #1 INSTALLATION AND TEST** |  | 2011-05-23 | 2011-09-07 |  |  |  |  |  |  |  |  |  |  |  |  |  |  |  |  |  |  |  |
| 131501000 |  | Installaton Cryomodule #1 | 5d | 2011-05-23 | 2011-05-27 | 3A-20M FS-80d, 131401000, 13436020, 4A-01M | 60d | 0d | MECH TECH [40 h] | 1,722.8 | HOGAN J | 1 | 1 | JOHN H | 08-050 | 10-031 | 10-064 | 10-065 | 10-066 |  |  |  |  |  |
| 131501005 |  | In-Tunnel Checkout and Commisioning Cryomodule #1 | 18d | 2011-08-12 | 2011-09-07 | 13213010, 131501000, 13436025, 132121061M, 132112081M | 19d | 0d | MECH TECH [160 h]; SUPPLIES & MATERIALS; SCIENTIST [40 h]; SR STAFF [40 h]; ELEC TECH [120 h]; COMP SCIENT [40 h]; ELEC ENG [240 h]; MECH ENG [80 h] | 48,691.5 | HOGAN J | 1 | 1 | JOHN H | 08-050 | 10-031 | 10-064 |  | 10-066 |  |  |  |  |  |
|  | 02 | **1.3.1.5.02 CRYOMODULE #2 INSTALLATION AND TEST** |  | 2011-07-21 | 2011-10-05 |  |  |  |  |  |  |  |  |  |  |  |  |  |  |  |  |  |  |  |
| 131502000 |  | Installaton Cryomodule #2 | 5d | 2011-07-21 | 2011-07-27 | 131402000, 13436030, 131501000 | 37d | 0d | MECH TECH [40 h] | 1,722.8 | HOGAN J | 1 | 1 | JOHN H | 08-050 | 10-031 | 10-064 | 10-065 | 10-066 | 11-012 |  |  |  |  |
| 131502005 |  | In-Tunnel Checkout and Commisioning Cryomodule #2 FY11 | 15d | 2011-09-12 | 2011-09-30 | 13436035, 132121062M, 132112082M, 13213010a, 131501005 FS-5d, 131502000 | 12d | 0d | ELEC TECH [100 h]; COMP SCIENT [33.33 h]; MECH ENG [66.67 h]; SUPPLIES & MATERIALS; MECH TECH [133.33 h]; SR STAFF [33.33 h]; SCIENTIST [33.33 h]; ELEC ENG [200 h] | 40,575.52 | HOGAN J | 1 | 1 | JOHN H | 08-050 | 10-031 | 10-064 |  | 10-066 |  | 12-001 |  |  |  |
| 131502005a |  | In-Tunnel Checkout and Commisioning Cryomodule #2 FY12 | 3d | 2011-10-03 | 2011-10-05 | 131502005 | 12d | 0d | SUPPLIES & MATERIALS; MECH TECH [26.67 h]; SR STAFF [6.67 h]; SCIENTIST [6.67 h]; ELEC ENG [40 h]; ELEC TECH [20 h]; COMP SCIENT [6.67 h]; MECH ENG [13.33 h] | 8,374.63 | HOGAN J | 1 | 1 | JOHN H | 08-050 | 10-031 | 10-064 |  | 10-066 |  | 12-001 |  |  |  |
|  | 03 | **1.3.1.5.03 CRYOMODULE #3 INSTALLATION AND TEST** |  | 2012-12-21 | 2013-01-11 |  |  |  |  |  |  |  |  |  |  |  |  |  |  |  |  |  |  |  |
| 131503000 |  | Installaton Cryomodule #3 5th | 10d | 2012-12-21 | 2013-01-11 | 132121065M, 131505000, 131403000, 2-02M, 13436055, 131502005a, 132112085M | 45d | 3d | MECH TECH [221.71 h] | 10,167.62 | HOGAN J | 1 | 1 | JOHN H | 08-050 | 10-031 | 10-064 |  | 10-066 |  |  | 12-018 | 12-028 | 13-003 |
|  | 04 | **1.3.1.5.04 CRYOMODULE #4 INSTALLATION AND TEST** |  | 2012-05-14 | 2012-07-13 |  |  |  |  |  |  |  |  |  |  |  |  |  |  |  |  |  |  |  |
| 131504000 |  | Installaton Cryomodule #4 3rd | 10d | 2012-05-14 | 2012-05-25 | 131404010 FS+30d, 131404000, 132121063M, 132112083M | 35d | 0d | MECH TECH [40 h] | 1,777.6 | HOGAN J | 1 | 1 | JOHN H | 08-050 | 10-031 | 10-064 |  | 10-066 |  |  | 12-018 | 12-028F |  |
| 131504005 |  | In-Tunnel Checkout and Commisioning Cryomodule #4 3rd | 23d | 2012-06-13 | 2012-07-13 | 13213010b, 131504000 | 312d | 3d | SCIENTIST [40 h]; ELEC ENG [240 h]; COMP SCIENT [16 h]; ELEC TECH [120 h]; MECH ENG [80 h]; SR STAFF [40 h]; MECH TECH [160 h]; SUPPLIES & MATERIALS | 48,668.41 | HOGAN J | 1 | 1 | JOHN H | 08-050 | 10-031 | 10-064 |  | 10-066 |  |  | 12-018 | 12-028 |  |
|  | 05 | **1.3.1.5.05 CRYOMODULE #5 INSTALLATION AND TEST** |  | 2012-05-29 | 2012-07-27 |  |  |  |  |  |  |  |  |  |  |  |  |  |  |  |  |  |  |  |
| 131505000 |  | Installaton Cryomodule #5 4th | 8d | 2012-05-29 | 2012-06-08 | 132112084M, 132113115, 131504000, 132121064M, 13436050, 131405000 | 35d | 0d | MECH TECH [40 h] | 1,777.6 | HOGAN J | 1 | 1 | JOHN H | 08-050 | 10-031 | 10-064 |  | 10-066 |  |  | 12-018 | 12-028F |  |
| 131505005 |  | In-Tunnel Checkout and Commisioning Cryomodule #5 4th | 25d | 2012-06-25 | 2012-07-27 | 131505000, 13213010c | 35d | 0d | COMP SCIENT [16 h]; SUPPLIES & MATERIALS; MECH ENG [80 h]; MECH TECH [160 h]; SCIENTIST [40 h]; ELEC ENG [240 h]; ELEC TECH [120 h]; SR STAFF [40 h] | 48,668.41 | HOGAN J | 1 | 1 | JOHN H | 08-050 | 10-031 | 10-064 |  | 10-066 |  |  | 12-018 | 12-028 |  |
|  | 06 | **1.3.1.5.06 CRYOMODULE #6 INSTALLATION AND TEST** |  | 2013-01-17 | 2013-01-30 |  |  |  |  |  |  |  |  |  |  |  |  |  |  |  |  |  |  |  |
| 131506000 |  | Installaton Cryomodule #6 | 9d | 2013-01-17 | 2013-01-30 | 132121066M, 131505005, 132112086M, 131406000, 131503000 | 57d | 5d | MECH TECH [221.71 h] | 10,167.62 | HOGAN J | 1 | 1 | JOHN H | 08-050 | 10-031 | 10-064 |  | 10-066 |  |  | 12-018 | 12-028 | 13-003 |
|  | 07 | **1.3.1.5.07 CRYOMODULE #7 INSTALLATION AND TEST** |  | 2013-02-07 | 2013-02-21 |  |  |  |  |  |  |  |  |  |  |  |  |  |  |  |  |  |  |  |
| 131507000 |  | Installaton Cryomodule #7 | 10d | 2013-02-07 | 2013-02-21 | 132112087M, 131506000, 132121067M, 131407000a | 66d | 3d | MECH TECH [221.71 h] | 10,167.62 | HOGAN J | 1 | 1 | JOHN H | 08-050 | 10-031 | 10-064 |  | 10-066 |  |  | 12-018 | 12-028 | 13-003 |
|  | 08 | **1.3.1.5.08 CRYOMODULE #8 INSTALLATION AND TEST** |  | 2013-02-27 | 2013-03-12 |  |  |  |  |  |  |  |  |  |  |  |  |  |  |  |  |  |  |  |
| 131508000 |  | Installaton Cryomodule #8 | 10d | 2013-02-27 | 2013-03-12 | 131408000, 132121068M, 132112088M, 131507000 | 78d | 3d | MECH TECH [221.71 h] | 10,167.62 | HOGAN J | 1 | 1 | JOHN H | 08-050 | 10-031 | 10-064 |  | 10-066 |  |  | 12-018 | 12-028 | 13-003 |
|  | 09 | **1.3.1.5.09 CRYOMODULE #9 INSTALLATION AND TEST** |  | 2013-03-18 | 2013-03-29 |  |  |  |  |  |  |  |  |  |  |  |  |  |  |  |  |  |  |  |
| 131509000 |  | Installaton Cryomodule #9 | 10d | 2013-03-18 | 2013-03-29 | 132112089M, 131508000, 131409000, 132121069M | 89d | 3d | MECH TECH [221.71 h] | 10,167.62 | HOGAN J | 1 | 1 | JOHN H | 08-050 | 10-031 | 10-064 |  | 10-066 |  |  | 12-018 | 12-028 | 13-003 |
|  | 10 | **1.3.1.5.10 CRYOMODULE #10 INSTALLATION AND TEST** |  | 2013-04-04 | 2013-04-17 |  |  |  |  |  |  |  |  |  |  |  |  |  |  |  |  |  |  |  |
| 131510000 |  | Installaton Cryomodule #10 | 10d | 2013-04-04 | 2013-04-17 | 132122030M, 131509000, 131410000, 132121070M, 132112090M | 100d | 65d | MECH TECH [221.71 h] | 10,167.62 | HOGAN J | 1 | 1 | JOHN H | 08-050 | 10-031 | 10-064 |  | 10-066 |  |  | 12-018 | 12-028 | 13-003 |

| ID | WBS | Activity | Type | Duration | Start | Finish | Predecessors | Total float | Free float | Constraint | Calendar | Resources | Cost | RESP - Responsibility | STRT%COMP for CM EVM | FNSH%COMP for CM EVM | CAM RESPONSIBLE | CR 11-045 | CR 13-014 | ReBaseline Actuals Adjustment | CR 08-050 | CR 10-027 | CR 10-064 | CR 11-003 | CR 11-012 | CR 11-051 | CR 12-018 | Milestone Level | CR 09-023 | Advance Purchase Plan > 500K | 12 GEV MAJOR PROCUREMENT CATAGORY | CR 10-001 | CR 12-028 | CR 10-028 | CR 10-066 | CR 11-015 | CR 08-016 | CR 09-012 | CR 10-031 | CR 13-009 | CR 11-001 | CR 12-001 | Profile change | CR 08-052 | Original Activity ID Rebaseline | BOE Labor | CR 13-015 | Post Rebaseline |
| --- | --- | --- | --- | --- | --- | --- | --- | --- | --- | --- | --- | --- | --- | --- | --- | --- | --- | --- | --- | --- | --- | --- | --- | --- | --- | --- | --- | --- | --- | --- | --- | --- | --- | --- | --- | --- | --- | --- | --- | --- | --- | --- | --- | --- | --- | --- | --- | --- |
|  | 6 | **1.3.1.6 MICROPHONICS** |  |  | 2011-06-01 | 2013-08-30 |  |  |  |  |  |  |  |  |  |  |  |  |  |  |  |  |  |  |  |  |  |  |  |  |  |  |  |  |  |  |  |  |  |  |  |  |  |  |  |  |  |  |
| 1316005 |  | Initial studies in accelerator tunnel |  | 22d | 2011-06-01 | 2011-06-30 | 9-110M FS+162d | 22d | 0d |  |  | ELEC ENG [548 h]; ELEC TECH [738 h]; MECH ENG [457.5 h]; MECH TECH [577.57 h] | 124,999.57 | HOGAN J | 1 | 1 | JOHN H | 11-045 |  |  |  |  |  |  |  |  |  |  |  |  |  |  |  |  |  |  |  |  |  |  |  |  |  |  |  |  |  |  |
| 1316010 |  | Analysis and mitigation development |  | 47d | 2011-06-24 | 2011-08-30 | 1316005 FS-5d | 22d |  |  |  | MECH TECH [290.23 h]; SCIENTIST [182.67 h]; MECH DES [267.78 h]; ELEC ENG [457 h]; ELEC TECH [292.26 h]; MECH ENG [643.86 h] | 125,000.2 | HOGAN J | 1 | 1 | JOHN H | 11-045 |  |  |  |  |  |  |  |  |  |  |  |  |  |  |  |  |  |  |  |  |  |  |  |  |  |  |  |  |  |  |
| 1316015 |  | Re-Baseline Actuals Adjustment |  | 1d | 2013-08-30 | 2013-08-30 | 9-130M FS+227d | 20d |  |  |  | PROCUREMENT>$50K 69 NO ESCALATION | 12,446.48 | HOGAN J | 1 | 1 | JOHN H |  | 13-014 | ADJ |  |  |  |  |  |  |  |  |  |  |  |  |  |  |  |  |  |  |  |  |  |  |  |  |  |  |  |  |
|  | 7 | **1.3.1.7 TEDF INTERFACE** |  |  | 2010-08-10 | 2012-07-13 |  |  |  |  |  |  |  |  |  |  |  |  |  |  |  |  |  |  |  |  |  |  |  |  |  |  |  |  |  |  |  |  |  |  |  |  |  |  |  |  |  |  |
| 1317000 |  | TEDF Summer Down 2010 |  | 22d | 2010-08-10 | 2010-09-09 | 9-100M FS+211d, 1311122010 | 37d | 0d |  |  |  |  | HOGAN J | 1 | 1 | JOHN H | 11-045 |  |  | 08-050 | 10-027 | 10-064 | 11-003 | 11-012 | 11-051 |  |  |  |  |  |  |  |  |  |  |  |  |  |  |  |  |  |  |  |  |  |  |
| 1317005 |  | TEDF Winter Down 2010 |  | 14d | 2010-12-20 | 2011-01-14 | 1312103050 FS-2d, 1311122030, 9-110M FS+54d | 99d | 0d |  |  |  |  | HOGAN J | 1 | 1 | JOHN H | 11-045 |  |  | 08-050 | 10-027 | 10-064 | 11-003 | 11-012 | 11-051 | 12-018F |  |  |  |  |  |  |  |  |  |  |  |  |  |  |  |  |  |  |  |  |  |
| 1317010 |  | TEDF Summer Down 2011 |  | 20d | 2011-07-01 | 2011-07-29 | 1311122087, 9-110M FS+184d, 1312108035, 1312405000 | 98d | 0d |  |  |  |  | HOGAN J | 1 | 1 | JOHN H | 11-045 |  |  | 08-050 | 10-027 | 10-064 | 11-003 | 11-012 | 11-051 | 12-018F |  |  |  |  |  |  |  |  |  |  |  |  |  |  |  |  |  |  |  |  |  |
| 1317020 |  | Transition - Planning and Coordination |  | 130d | 2011-10-03 | 2012-04-13 | 9-120M | 0d |  |  |  |  |  | HOGAN J | 1 | 1 | JOHN H | 11-045 |  |  | 08-050 | 10-027 | 10-064 |  |  | 11-051 | 12-018F |  |  |  |  |  |  |  |  |  |  |  |  |  |  |  |  |  |  |  |  |  |
| 1317015 |  | TEDF Winter Down 2011 |  | 18d | 2011-12-19 | 2012-01-20 | 9-120M FS+53d | 79d |  |  |  |  |  | HOGAN J | 1 | 1 | JOHN H | 11-045 |  |  | 08-050 | 10-027 | 10-064 |  |  |  |  |  |  |  |  |  |  |  |  |  |  |  |  |  |  |  |  |  |  |  |  |  |
| 1317025 |  | Transition - Cryomodule Work Center |  | 40d | 2012-04-02 | 2012-05-25 | 1317020 FS-10d | 0d |  | mandatory start 2012-04-02 |  |  |  | HOGAN J | 1 | 1 | JOHN H | 11-045 |  |  | 08-050 | 10-027 | 10-064 |  |  | 11-051 | 12-018 |  |  |  |  |  |  |  |  |  |  |  |  |  |  |  |  |  |  |  |  |  |
| 1317035 |  | CMTF Down - TL Renovation |  | 33d | 2012-05-29 | 2012-07-13 | 1317025 | 0d |  | mandatory finish 2012-07-13 |  |  |  | HOGAN J | 1 | 1 | JOHN H | 11-045 |  |  | 08-050 | 10-027 | 10-064 |  |  | 11-051 | 12-018 |  |  |  |  |  |  |  |  |  |  |  |  |  |  |  |  |  |  |  |  |  |
|  | 2 | **1.3.2 POWER SYSTEMS** |  |  | 2009-01-02 | 2014-09-30 |  |  |  |  |  |  |  |  |  |  |  |  |  |  |  |  |  |  |  |  |  |  |  |  |  |  |  |  |  |  |  |  |  |  |  |  |  |  |  |  |  |  |
|  | 1 | **1.3.2.1 RF** |  |  | 2009-04-21 | 2013-11-06 |  |  |  |  |  |  |  |  |  |  |  |  |  |  |  |  |  |  |  |  |  |  |  |  |  |  |  |  |  |  |  |  |  |  |  |  |  |  |  |  |  |  |
|  | 1 | **1.3.2.1.1 POWER** |  |  | 2009-04-21 | 2013-09-30 |  |  |  |  |  |  |  |  |  |  |  |  |  |  |  |  |  |  |  |  |  |  |  |  |  |  |  |  |  |  |  |  |  |  |  |  |  |  |  |  |  |  |
|  | 1 | **1.3.2.1.1.1 KLYSTRONS** |  |  | 2009-04-21 | 2013-09-30 |  |  |  |  |  |  |  |  |  |  |  |  |  |  |  |  |  |  |  |  |  |  |  |  |  |  |  |  |  |  |  |  |  |  |  |  |  |  |  |  |  |  |
| 132111025M |  | Klystron Contract Awarded (KLYSTRONS) | milestone | 0d | 2009-04-21 | 2009-04-21 | 1212111120, 9-090M FS+134d | -37d | 0d |  |  |  |  | NELSON R | 1 | 1 | BILL M |  |  |  |  |  |  |  |  |  |  | 6 | 09-023 |  |  |  |  |  |  |  |  |  |  |  |  |  |  |  |  |  |  |  |
| 132111030 |  | Vend Dsgn Period (Klystrons) |  | 77d | 2009-04-21 | 2009-08-07 | 132111025M, 32-01M | 154d | 0d |  |  | PROCUREMENT<$50K 60 NO ESCALATION; PROCUREMENT>$50K 69 NO ESCALATION | 98,456 | NELSON R | 1 | 1 | BILL M |  |  |  |  |  |  |  |  |  |  |  | 09-023 | APP | 32111 | 10-001A | 12-028F |  |  |  |  |  |  |  |  |  |  |  |  |  |  |  |
| 132111035 |  | Klystron Dsgn Review & Approval for Production (Klystrons) |  | 5d | 2009-08-10 | 2009-08-14 | 132111030 | 154d | 0d |  |  | ELEC ENG [88 h]; ELEC DES [80 h] | 9,330.64 | NELSON R | 1 | 1 | BILL M |  |  |  |  |  |  |  |  |  |  |  | 09-023 |  |  |  | 12-028F |  |  |  |  |  |  |  |  |  |  |  |  |  |  |  |
| 132111040 |  | Vend Manufacture First article Klystron (Order and Recieve Parts) |  | 69d | 2009-08-17 | 2009-11-20 | 132111035 | 347d | 150d |  |  | PROCUREMENT<$50K 60 NO ESCALATION; PROCUREMENT>$50K 69 NO ESCALATION | 147,684 | NELSON R | 1 | 1 | BILL M |  |  |  |  |  | 10-064 |  |  |  | 12-018F |  | 09-023 |  |  | 10-001A |  | 10-028 | 10-066 | 11-015 |  |  |  |  |  |  |  |  |  |  |  |  |
| 132111040A |  | Vend Manufacture First article Klystron (First Article Testing) |  | 167d | 2009-08-17 | 2010-04-21 | 132111035 | 206d | 52d |  |  | PROCUREMENT<$50K 60 NO ESCALATION; PROCUREMENT>$50K 69 NO ESCALATION | 196,912 | NELSON R | 1 | 1 | BILL M |  |  |  |  |  | 10-064 |  |  |  | 12-018F |  | 09-023 |  |  | 10-001A |  | 10-028 | 10-066 | 11-015 |  |  |  |  |  |  |  |  |  |  |  |  |
| 132111040B |  | Vend Manufacture First article Klystron (Delivery of FA Report) |  | 219d | 2009-08-17 | 2010-07-06 | 132111035 | 154d | 0d |  |  | PROCUREMENT<$50K 60 NO ESCALATION; PROCUREMENT>$50K 69 NO ESCALATION | 49,228 | NELSON R | 1 | 1 | BILL M |  |  |  |  |  | 10-064 |  |  |  | 12-018F |  | 09-023 |  |  | 10-001A |  | 10-028 | 10-066 | 11-015 |  |  |  |  |  |  |  |  |  |  |  |  |
| 132111042 |  | Vend Manufacture First article Klystron (Klystrons) LABOR/EXPS FY09 |  | 32d | 2009-08-17 | 2009-09-30 | 132111035 | 154d | 0d |  |  | SUPPLIES & MATERIALS | 805.8 | NELSON R | 1 | 1 | BILL M |  |  |  |  |  | 10-064 |  |  |  | 12-018F |  | 09-023 |  |  | 10-001B |  | 10-028 | 10-066 | 11-015 |  |  |  |  |  |  |  |  |  |  |  |  |
| 132111042b |  | Vend Manufacture First article Klystron (Klystrons) LABOR/EXPS FY10 |  | 187d | 2009-10-01 | 2010-07-06 | 132111042 | 154d | 0d |  |  | SUPPLIES & MATERIALS | 4,859.1 | NELSON R | 1 | 1 | BILL M |  |  |  |  |  | 10-064 |  |  |  | 12-018F |  |  |  |  | 10-001B |  | 10-028 | 10-066 | 11-015 |  |  |  |  |  |  |  |  |  |  |  |  |
| 132111911LOE |  | Proj Admin (2011) ongoing (Klystrons) |  | 248d | 2009-10-01 | 2010-09-30 | 9-100M | 20d | 0d |  |  | SR STAFF [880 h] | 93,385.6 | NELSON R | 1 | 1 | BILL M |  |  |  |  |  |  |  |  |  |  |  |  |  |  |  |  |  |  |  |  |  |  |  |  |  |  |  |  |  |  |  |
| 132111045 |  | Test First article Klystron (Klystrons) |  | 10d | 2010-04-21 | 2010-05-04 | 132111040 FS-53d, 132111040A FS-53d, 132111042b FS-53d, 132111040B FS-53d | 197d | 43d |  |  | TRAVEL; SUPPLIES & MATERIALS; ELEC TECH [40 h]; ELEC DES [80 h]; ELEC ENG [40 h] | 14,334.1 | NELSON R | 1 | 1 | BILL M |  |  |  |  |  | 10-064 |  |  |  | 12-018F |  | 09-023 |  |  |  |  | 10-028 | 10-066 | 11-015 |  |  |  |  |  |  |  |  |  |  |  |  |
| 132111049 |  | Grant Approval for Klystron Production, (Klystrons) |  | 5d | 2010-07-07 | 2010-07-13 | 132111040A, 132111042b, 9-100M FS+60d, 132111045, 132111040B | 154d | 0d |  |  | ELEC ENG [12 h] | 795.24 | NELSON R | 1 | 1 | BILL M |  |  |  |  |  | 10-064 |  |  |  | 12-018F |  | 09-023 |  |  |  |  | 10-028 | 10-066 | 11-015 |  |  |  |  |  |  |  |  |  |  |  |  |
| 132111049M |  | Start of Klystron Production | milestone | 0d | 2010-07-14 | 2010-07-14 | 132111049 | 154d | 0d |  |  |  |  | NELSON R | 1 | 1 | BILL M |  |  |  |  |  | 10-064 |  |  |  | 12-018F |  | 09-023 |  |  |  |  | 10-028 | 10-066 | 11-015 |  |  |  |  |  |  |  |  |  |  |  |  |
| 132111050 |  | Vend Klystron Production (Klystron 1&2) |  | 176d | 2010-07-14 | 2011-03-31 | 2-01M, 132111049M | 262d | 0d |  |  | PROCUREMENT<$50K 60 NO ESCALATION; PROCUREMENT>$50K 69 NO ESCALATION | 73,514 | NELSON R | 1 | 1 | BILL M |  |  |  |  |  |  |  |  |  |  |  | 09-023 | APP | 32111 | 10-001A | 12-028F | 10-028 |  | 11-015 | 08-016 | 09-012 |  |  |  |  |  |  |  |  |  |  |
| 132111050A |  | Vend Klystron Production (Klystrons 3-6) |  | 197d | 2010-07-14 | 2011-04-29 | 2-01M, 132111049M | 612d | 350d |  |  | PROCUREMENT>$50K 69 NO ESCALATION | 147,028.03 | NELSON R | 1 | 1 | BILL M |  |  |  |  |  |  |  |  |  |  |  | 09-023 | APP | 32111 | 10-001A | 12-028F | 10-028 |  | 11-015 | 08-016 | 09-012 |  |  |  |  |  |  |  |  |  |  |
| 132111050B |  | Vend Klystron Production (Klystrons 7-10) |  | 217d | 2010-07-14 | 2011-05-27 | 2-01M, 132111049M | 592d | 330d |  |  | PROCUREMENT>$50K 69 NO ESCALATION | 147,028.03 | NELSON R | 1 | 1 | BILL M |  |  |  |  |  |  |  |  |  |  |  | 09-023 | APP | 32111 | 10-001A | 12-028F | 10-028 |  | 11-015 | 08-016 | 09-012 |  |  |  |  |  |  |  |  |  |  |
| 132111050C |  | Vend Klystron Production (Klystrons 11-14) |  | 240d | 2010-07-14 | 2011-06-30 | 2-01M, 132111049M | 569d | 307d |  |  | PROCUREMENT>$50K 69 NO ESCALATION | 147,028.03 | NELSON R | 1 | 1 | BILL M |  |  |  |  |  |  |  |  |  |  |  | 09-023 | APP | 32111 | 10-001A | 12-028F | 10-028 |  | 11-015 | 08-016 | 09-012 |  |  |  |  |  |  |  |  |  |  |
| 132111050D |  | Vend Klystron Production (Klystrons 15&16) |  | 260d | 2010-07-14 | 2011-07-29 | 2-01M, 132111049M | 549d | 287d |  |  | PROCUREMENT>$50K 69 NO ESCALATION | 73,514 | NELSON R | 1 | 1 | BILL M |  |  |  |  |  |  |  |  |  |  |  | 09-023 | APP | 32111 | 10-001A | 12-028F | 10-028 |  | 11-015 | 08-016 | 09-012 |  |  |  |  |  |  |  |  |  |  |
| 132111050F |  | Vend Klystron Production (Klystrons 17-19) |  | 260d | 2010-07-14 | 2011-07-29 | 2-01M, 132111049M | 549d | 287d |  |  | PROCUREMENT>$50K 69 NO ESCALATION | 110,271.03 | NELSON R | 1 | 1 | BILL M |  |  |  |  |  |  |  |  |  |  |  | 09-023 | APP | 32111 | 10-001A | 12-028F | 10-028 |  | 11-015 | 08-016 | 09-012 |  |  |  |  |  |  |  |  |  |  |
| 132111050G |  | Vend Klystron Production (Klystrons 20-24) |  | 283d | 2010-07-14 | 2011-08-31 | 2-01M, 132111049M | 526d | 264d |  |  | PROCUREMENT>$50K 69 NO ESCALATION | 183,785.05 | NELSON R | 1 | 1 | BILL M |  |  |  |  |  |  |  |  |  |  |  | 09-023 | APP | 32111 | 10-001A | 12-028F | 10-028 |  | 11-015 | 08-016 | 09-012 |  |  |  |  |  |  |  |  |  |  |
| 132111050H |  | Vend Klystron Production (Klystrons 25-30) |  | 304d | 2010-07-14 | 2011-09-30 | 2-01M, 132111049M | 505d | 243d |  |  | PROCUREMENT>$50K 69 NO ESCALATION | 220,541.96 | NELSON R | 1 | 1 | BILL M |  |  |  |  |  |  |  |  |  |  |  | 09-023 | APP | 32111 | 10-001A | 12-028F | 10-028 |  | 11-015 | 08-016 | 09-012 |  |  |  |  |  |  |  |  |  |  |
| 132111050J |  | Vend Klystron Production (Klystrons 37-42) |  | 345d | 2010-07-14 | 2011-11-30 | 132111049M, 2-01M | 154d | 0d |  |  | PROCUREMENT>$50K 69 NO ESCALATION | 220,541.96 | NELSON R | 1 | 1 | BILL M |  |  |  |  |  | 10-064 |  |  |  | 12-018F |  | 09-023 | APP | 32111 | 10-001A |  | 10-028 | 10-066 | 11-015 | 08-016 | 09-012 | 10-031 |  |  |  |  |  |  |  |  |  |
| 132111050K |  | Vend Klystron Production (Klystrons 43-48) |  | 362d | 2010-07-14 | 2011-12-30 | 132111049M, 2-01M | 447d | 185d |  |  | PROCUREMENT>$50K 69 NO ESCALATION | 220,541.96 | NELSON R | 1 | 1 | BILL M |  |  |  |  |  |  |  |  |  |  |  | 09-023 | APP | 32111 | 10-001A | 12-028F | 10-028 |  | 11-015 | 08-016 | 09-012 |  |  |  |  |  |  |  |  |  |  |
| 132111050L |  | Vend Klystron Production (Klystrons 49-54) |  | 382d | 2010-07-14 | 2012-01-31 | 2-01M, 132111049M | 427d | 165d |  |  | PROCUREMENT>$50K 69 NO ESCALATION | 220,541.96 | NELSON R | 1 | 1 | BILL M |  |  |  |  |  |  |  |  |  |  |  | 09-023 | APP | 32111 | 10-001A | 12-028F | 10-028 |  | 11-015 | 08-016 | 09-012 |  |  |  |  |  |  |  |  |  |  |
| 132111050N |  | Vend Klystron Production (Klystrons 55-60) |  | 402d | 2010-07-14 | 2012-02-29 | 2-01M, 132111049M | 407d | 145d |  |  | PROCUREMENT>$50K 69 NO ESCALATION | 220,541.96 | NELSON R | 1 | 1 | BILL M |  |  |  |  |  |  |  |  |  |  |  | 09-023 | APP | 32111 | 10-001A | 12-028F | 10-028 |  | 11-015 | 08-016 | 09-012 |  |  |  |  |  |  |  |  |  |  |
| 132111050P |  | Vend Klystron Production (Klystrons 67-72) |  | 445d | 2010-07-14 | 2012-04-30 | 2-01M, 132111049M | 364d | 102d |  |  | PROCUREMENT>$50K 69 NO ESCALATION | 220,541.96 | NELSON R | 1 | 1 | BILL M |  |  |  |  |  |  |  |  |  |  |  | 09-023 | APP | 32111 | 10-001A | 12-028F | 10-028 |  | 11-015 | 08-016 | 09-012 |  |  |  |  |  |  |  |  |  |  |
| 132111050Q |  | Vend Klystron Production (Klystrons 73-78) |  | 467d | 2010-07-14 | 2012-05-31 | 2-01M, 132111049M | 342d | 80d |  |  | PROCUREMENT>$50K 69 NO ESCALATION | 220,541.96 | NELSON R | 1 | 1 | BILL M |  |  |  |  |  |  |  |  |  |  |  | 09-023 | APP | 32111 | 10-001A | 12-028F | 10-028 |  | 11-015 | 08-016 | 09-012 |  |  |  |  |  |  |  |  |  |  |
| 132111050R |  | Vend Klystron Production (Klystrons 79-83) |  | 487d | 2010-07-14 | 2012-06-29 | 2-01M, 132111049M | 322d | 60d |  |  | PROCUREMENT>$50K 69 NO ESCALATION | 183,785.19 | NELSON R | 1 | 1 | BILL M |  |  |  |  |  |  |  |  |  |  |  | 09-023 | APP | 32111 | 10-001A | 12-028F | 10-028 |  | 11-015 | 08-016 | 09-012 |  |  |  |  |  |  |  |  |  |  |
| 132111050i |  | Vend Klystron Production (Klystrons 31-36) |  | 325d | 2010-07-14 | 2011-10-31 | 2-01M, 132111049M | 484d | 222d |  |  | PROCUREMENT>$50K 69 NO ESCALATION | 220,541.96 | NELSON R | 1 | 1 | BILL M |  |  |  |  |  |  |  |  |  |  |  | 09-023 | APP | 32111 | 10-001A | 12-028F | 10-028 |  | 11-015 | 08-016 | 09-012 |  |  |  |  |  |  |  |  |  |  |
| 132111050o |  | Vend Klystron Production (Klystrons 61-66) |  | 424d | 2010-07-14 | 2012-03-30 | 132111049M, 2-01M | 272d | 123d |  |  | PROCUREMENT>$50K 69 NO ESCALATION | 220,541.96 | NELSON R | 1 | 1 | BILL M |  |  |  |  |  | 10-064 |  |  |  | 12-018F |  | 09-023 | APP | 32111 | 10-001A | 12-028F | 10-028 | 10-066 | 11-015 | 08-016 | 09-012 | 10-031 | 13-009F |  |  |  |  |  |  |  |  |
| 132111052 |  | Vend Klystron Production LABOR/EXP FY10 |  | 56d | 2010-07-14 | 2010-09-30 | 132111049M | 354d | 0d |  |  | SUPPLIES & MATERIALS; ELEC ENG [1.97 h] | 1,526.16 | NELSON R | 1 | 1 | BILL M |  |  |  |  |  |  |  |  |  |  |  | 09-023 | APP | 32111 |  | 12-028F | 10-028 |  |  | 08-016 | 09-012 |  |  | 11-001 |  |  |  |  |  |  |  |
| 132111052a |  | Vend Klystron Production LABOR/EXP FY11 |  | 248d | 2010-10-01 | 2011-09-30 | 132111052 | 354d | 0d |  |  | SUPPLIES & MATERIALS; ELEC ENG [8.72 h] | 6,974.09 | NELSON R | 1 | 1 | BILL M |  |  |  |  |  |  |  |  |  |  |  | 09-023 | APP | 32111 |  | 12-028F | 10-028 |  |  | 08-016 | 09-012 |  |  | 11-001 | 12-001 |  |  |  |  |  |  |
| 132111912LOE |  | Proj Admin (2012) ongoing (Klystrons) |  | 248d | 2010-10-01 | 2011-09-30 | 132111911LOE | 20d | 0d |  |  | SR STAFF [880 h] | 96,368.8 | NELSON R | 1 | 1 | BILL M |  |  |  |  |  |  |  |  |  |  |  |  |  |  |  |  |  |  |  |  |  |  |  |  |  |  |  |  |  |  |  |
| 132111060 |  | Release Prcrmnt Package, Driver Amplifer (Klystrons) |  | 5d | 2010-12-07 | 2010-12-13 | 9-110M FS+45d, 132111049 | 293d | 0d |  |  | ELEC ENG [4 h] | 273.52 | NELSON R | 1 | 1 | BILL M |  |  |  |  |  |  |  |  |  |  |  |  |  |  |  | 12-028F | 10-028 |  |  |  |  |  |  |  |  |  |  |  |  |  |  |
| 132111065 |  | Receive & Evaluate Driver Amplifer Proposals (Klystrons) |  | 30d | 2010-12-14 | 2011-02-02 | 132111060 | 293d | 0d |  |  | ELEC ENG [20 h] | 1,367.6 | NELSON R | 1 | 1 | BILL M |  |  |  |  |  |  |  |  |  |  |  |  |  |  |  | 12-028F | 10-028 |  |  |  |  |  |  |  |  |  |  |  |  |  |  |
| 132111068 |  | Bid Driver Amplifer Prcrmnt (Klystrons) |  | 10d | 2011-02-03 | 2011-02-16 | 132111065 | 293d | 0d |  |  | ELEC ENG [4 h] | 273.52 | NELSON R | 1 | 1 | BILL M |  |  |  |  |  |  |  |  |  |  |  |  |  |  |  | 12-028F | 10-028 |  |  |  |  |  |  |  |  |  |  |  |  |  |  |
| 132111069M |  | Award Driver Amplifer Prcrmnt (KLYSTRONS) | milestone | 0d | 2011-02-17 | 2011-02-17 | 9-110M, 132111068 | 293d | 0d |  |  |  |  | NELSON R | 1 | 1 | BILL M |  |  |  |  |  |  |  |  |  |  | 6 |  |  |  |  | 12-028F | 10-028 |  |  |  |  |  |  |  |  | C |  |  |  |  |  |
| 132111070 |  | Vend Fab Driver Amplifer 1st Article (Klystrons) |  | 10d | 2011-02-17 | 2011-03-03 | 132111069M | 293d | 0d |  |  | PROCUREMENT<$50K 60 | 30,155.51 | NELSON R | 1 | 1 | BILL M |  |  |  |  |  |  |  |  |  |  |  |  | APP |  |  | 12-028F | 10-028 |  |  |  |  |  |  |  |  |  |  |  |  |  |  |
| 132111075 |  | Dsgn Review for Driver Amplifer (Klystrons) |  | 30d | 2011-03-04 | 2011-04-14 | 132111070 | 293d | 0d |  |  | ELEC ENG [8 h] | 547.04 | NELSON R | 1 | 1 | BILL M |  |  |  |  |  |  |  |  |  |  |  |  |  |  |  | 12-028F | 10-028 |  |  |  |  |  |  |  |  |  |  |  |  |  |  |
| 132111055 |  | Receive & Test Production Klystrons FY11 |  | 128d | 2011-04-01 | 2011-09-30 | 132111050 | 262d | 0d |  |  | ELEC TECH [193.21 h]; ELEC ENG [41.4 h] | 11,094.52 | NELSON R | 1 | 1 | BILL M |  |  |  |  |  |  |  |  |  |  |  | 09-023 |  |  |  | 12-028F | 10-028 |  | 11-015 |  |  |  |  |  | 12-001 |  |  |  |  |  |  |
| 132111080 |  | Vendor Fab Lot 1 Driver Amplifers (Klystrons) Labor FY11 |  | 118d | 2011-04-15 | 2011-09-30 | 132111075 | 293d | 0d |  |  | ELEC TECH [36.31 h]; ELEC ENG [7.26 h] | 2,049.42 | NELSON R | 1 | 1 | BILL M |  |  |  |  |  |  |  |  |  |  |  |  | APP |  |  | 12-028F | 10-028 |  |  | 08-016 | 09-012 |  |  |  | 12-001 |  |  |  |  |  |  |
| 132111080b |  | Vendor Fab Lot 1 Driver Amplifers (Klystrons) Procurement |  | 130d | 2011-04-15 | 2011-10-18 | 132111075 | 293d | 0d |  |  | PROCUREMENT<$50K 60 NO ESCALATION FY12 | 28,345.91 | NELSON R | 1 | 1 | BILL M |  |  |  |  |  |  |  |  |  |  |  |  | APP |  |  | 12-028F | 10-028 |  |  | 08-016 | 09-012 |  |  |  | 12-001 |  |  |  |  |  |  |
| 132111052ab |  | Vend Klystron Production LABOR/EXP FY12 |  | 151d | 2011-10-03 | 2012-05-14 | 132111052a | 354d | 92d |  |  | SUPPLIES & MATERIALS; ELEC ENG [5.31 h] | 4,381.8 | NELSON R | 1 | 1 | BILL M |  |  |  |  |  |  |  |  |  |  |  | 09-023 | APP | 32111 |  | 12-028F | 10-028 |  |  | 08-016 | 09-012 |  |  | 11-001 | 12-001 |  |  |  |  |  |  |
| 132111055a |  | Receive & Test Production Klystrons FY12 |  | 243d | 2011-10-03 | 2012-09-24 | 132111055 | 262d | 0d |  |  | ELEC TECH [366.79 h]; ELEC ENG [78.6 h] | 21,732.46 | NELSON R | 1 | 1 | BILL M |  |  |  |  |  |  |  |  |  |  |  | 09-023 |  |  |  | 12-028F | 10-028 |  | 11-015 |  |  |  |  |  | 12-001 |  |  |  |  |  |  |
| 132111080a |  | Vendor Fab Lot 1 Driver Amplifers (Klystrons) Labor FY12 |  | 12d | 2011-10-03 | 2011-10-18 | 132111080 | 293d | 0d |  |  | ELEC TECH [3.69 h]; ELEC ENG [0.74 h] | 215.05 | NELSON R | 1 | 1 | BILL M |  |  |  |  |  |  |  |  |  |  |  |  | APP |  |  | 12-028F | 10-028 |  |  | 08-016 | 09-012 |  |  |  | 12-001 |  |  |  |  |  |  |
| 132111913LOE |  | Proj Admin (2013) ongoing (Klystrons) |  | 247d | 2011-10-03 | 2012-09-28 | 132111912LOE | 20d | 0d |  |  | SR STAFF [600 h] | 67,800 | NELSON R | 1 | 1 | BILL M |  |  |  |  |  |  |  |  |  |  |  |  |  |  |  |  |  |  |  |  |  |  |  |  |  |  |  |  |  |  |  |
| 132111115 |  | Vendor Fab Lot 2 of Driver Amplifers (Klystrons) |  | 200d | 2011-10-19 | 2012-08-09 | 132111080b, 132111080a, 9-120M | 293d | 0d |  |  | PROCUREMENT<$50K 60 | 61,573.91 | NELSON R | 1 | 1 | BILL M |  |  |  |  |  |  |  |  |  |  |  |  | APP |  |  | 12-028F | 10-028 |  |  |  |  |  |  |  |  |  |  |  |  |  |  |
| 132111115M |  | Driver amplfier Prcrmnt Comp (KLYSTRONS) | milestone | 0d | 2012-08-09 | 2012-08-09 | 132111115 | 293d | 158d |  |  |  |  | NELSON R | 1 | 1 | BILL M |  |  |  |  |  |  |  |  |  |  | 6 |  |  |  |  | 12-028F | 10-028 |  |  |  |  |  |  |  |  |  |  |  |  |  |  |
| 132111057M |  | Production Klystrons Received and Tested | milestone | 0d | 2012-09-24 | 2012-09-24 | 132111050, 132111050Q, 132111052ab, 132111050o, 132111055a, 132111050L, 132111050D, 132111050F, 132111050G, 132111050N, 132111050A, 132111050C, 132111050i, 132111050K, 132111050P, 132111050R, 132111050H, 132111050B, 132111050J | 262d | 127d |  |  |  |  | NELSON R | 1 | 1 | BILL M |  |  |  |  |  |  |  |  |  |  |  | 09-023 |  |  |  | 12-028F | 10-028 |  | 11-015 |  |  |  |  |  |  |  |  |  |  |  |  |
| 132111914LOE |  | Proj Admin (2014) ongoing (Klystrons) *** Re-Baseline Split |  | 228d | 2012-10-01 | 2013-08-30 | 132111913LOE | 20d |  |  |  | SR STAFF [183.87 h] | 21,439.24 | NELSON R | 1 | 1 | BILL M |  | 13-014 |  |  |  |  |  |  |  |  |  |  |  |  |  |  |  |  |  |  |  |  |  |  |  |  | 08-052 |  |  |  |  |
| 132111950 |  | Re-Baseline Actuals Adjustment |  | 1d | 2013-08-30 | 2013-08-30 | 9-130M FS+227d | 20d |  |  |  | PROCUREMENT>$50K 69 NO ESCALATION | -36,764.16 | NELSON R | 1 | 1 | BILL M |  | 13-014 | ADJ |  |  |  |  |  |  |  |  |  |  |  |  |  |  |  |  |  |  |  |  |  |  |  |  |  |  |  |  |
| 232111914LOE |  | Proj Admin ongoing (Klystrons) |  | 20d | 2013-09-03 | 2013-09-30 | 9-130M FS+228d | 58d | 0d |  | 8/5 M-F w/JLAB Holidays ReBaseline | SR STAFF [16.13 h] | 1,880.76 | NELSON R | 1 | 1 | BILL M |  |  |  |  |  |  |  |  |  |  |  |  |  |  |  |  |  |  |  |  |  |  |  |  |  |  | 08-052 | 232111914LOE | EJ | 13-015 | PR |

| ID | WBS | Activity | Type | Duration | Start | Finish | Predecessors | Total float | Free float | Resources | Cost | RESP - Responsibility | STRT%COMP for CM EVM | FNSH%COMP for CM EVM | Milestone Level | CAM RESPONSIBLE | CR 08-049 | CR 08-052 | CR 10-028 | CR 10-031 | CR 10-064 | CR 10-066 | CR 12-028 | CR 11-015 | CR 12-018 | CR 11-043 | CR 13-009 | 12 GEV MAJOR PROCUREMENT CATAGORY | CR 10-036 | CR 13-014 | ReBaseline Actuals Adjustment |
| --- | --- | --- | --- | --- | --- | --- | --- | --- | --- | --- | --- | --- | --- | --- | --- | --- | --- | --- | --- | --- | --- | --- | --- | --- | --- | --- | --- | --- | --- | --- | --- |
|  | 2 | **1.3.2.1.1.2 DC POWER** |  |  | 2009-06-18 | 2013-08-30 |  |  |  |  |  |  |  |  |  |  |  |  |  |  |  |  |  |  |  |  |  |  |  |  |  |
| 132112081M |  | First Zone Installed/Tested (DC Power) | milestone | 0d | 2011-08-04 | 2011-08-04 | 4A-03M, 1321122100 | 19d | 0d |  |  | NELSON R | 1 | 1 | 6 | BILL M | 08-049 | 08-052 | 10-028 | 10-031 | 10-064 | 10-066 |  |  |  |  |  |  |  |  |  |
| 132112082M |  | Second Zone Installed/Tested (DC Power) | milestone | 0d | 2011-09-01 | 2011-09-01 | 1321122105 | 12d | 0d |  |  | NELSON R | 1 | 1 | 6 | BILL M | 08-049 | 08-052 | 10-028 | 10-031 | 10-064 | 10-066 |  |  |  |  |  |  |  |  |  |
| 132112083M |  | Third Zone Installed/Tested (DC Power) | milestone | 0d | 2011-09-30 | 2011-09-30 | 1321122110 | 185d | 41d |  |  | NELSON R | 1 | 1 | 6 | BILL M | 08-049 | 08-052 | 10-028 | 10-031 | 10-064 | 10-066 | 12-028F |  |  |  |  |  |  |  |  |
| 132112084M |  | Fourth Zone Installed/Tested (DC Power) | milestone | 0d | 2011-11-30 | 2011-11-30 | 1321122115a, 132121064M FS+25d, 132111050J, 132112083M | 154d | 119d |  |  | NELSON R | 1 | 1 | 6 | BILL M | 08-049 | 08-052 | 10-028 | 10-031 | 10-064 | 10-066 |  | 11-015 | 12-018F |  |  |  |  |  |  |
| 132112085M |  | Fifth Zones Installed/Tested (DC Power) | milestone | 0d | 2012-12-20 | 2012-12-20 | 1321122120a FS+264d | 45d | 0d |  |  | NELSON R | 1 | 1 | 6 | BILL M | 08-049 | 08-052 | 10-028 | 10-031 | 10-064 | 10-066 | 12-028 |  | 12-018F |  |  |  |  |  |  |
| 132112086M |  | Sixth Zone Installed/Tested (DC Power) | milestone | 0d | 2013-01-16 | 2013-01-16 | 1321122185, 1321122125 | 51d | 0d |  |  | NELSON R | 1 | 1 | 6 | BILL M | 08-049 | 08-052 | 10-028 | 10-031 | 10-064 | 10-066 | 12-028 |  | 12-018F | 11-043 | 13-009F |  |  |  |  |
| 132112087M |  | Seventh Zone Installed/Tested (DC Power) | milestone | 0d | 2013-02-06 | 2013-02-06 | 132111050o, 1321122190, 1321122130, 132121067M FS+25d, 132112086M | 61d | 0d |  |  | NELSON R | 1 | 1 | 6 | BILL M | 08-049 | 08-052 | 10-028 | 10-031 | 10-064 | 10-066 | 12-028 |  | 12-018F | 11-043 | 13-009F |  |  |  |  |
| 132112088M |  | Eighth Zone Installed/Tested (DC Power) | milestone | 0d | 2013-02-26 | 2013-02-26 | 1321122195, 1321122135 | 73d | 0d |  |  | NELSON R | 1 | 1 | 6 | BILL M | 08-049 | 08-052 | 10-028 | 10-031 | 10-064 | 10-066 | 12-028 |  | 12-018F | 11-043 | 13-009F |  |  |  |  |
| 132112089M |  | Ninth Zone Installed/Tested (DC Power) | milestone | 0d | 2013-03-15 | 2013-03-15 | 1321122200, 1321122140 | 84d | 0d |  |  | NELSON R | 1 | 1 | 6 | BILL M | 08-049 | 08-052 | 10-028 | 10-031 | 10-064 | 10-066 | 12-028 |  | 12-018F | 11-043 | 13-009F |  |  |  |  |
| 132112090M |  | Tenth Zone Installed/Tested (DC Power) | milestone | 0d | 2013-04-03 | 2013-04-03 | 1321122205, 1321122145, 1321122015a, 1321122047LOE, 1321122030a, 1321121035 | 95d | 0d |  |  | NELSON R | 1 | 1 | 6 | BILL M | 08-049 | 08-052 | 10-028 | 10-031 | 10-064 | 10-066 | 12-028 |  | 12-018F | 11-043 | 13-009F |  |  |  |  |
|  | 1 | **1.3.2.1.1.2.1 High Voltage Power Supply** |  |  | 2009-06-18 | 2013-08-30 |  |  |  |  |  |  |  |  |  |  |  |  |  |  |  |  |  |  |  |  |  |  |  |  |  |
| 1321121000 |  | Bid HVPS |  | 31d | 2009-06-18 | 2009-07-31 | 9-090M FS+175d | 81d | 0d | ELEC ENG [40 h] | 2,569.2 | NELSON R | 1 | 1 |  | BILL M | 08-049 |  |  |  |  |  |  |  |  |  |  |  |  |  |  |
| 1321121005 |  | Evaluate HVPS |  | 33d | 2009-08-03 | 2009-09-17 | 1321121000 | 81d | 9d | ELEC ENG [80 h] | 5,138.4 | NELSON R | 1 | 1 |  | BILL M | 08-049 |  |  |  |  |  |  |  |  |  |  |  |  |  |  |
| 1321121010 |  | Award HVPS Lot 1 (3) |  | 5d | 2009-10-01 | 2009-10-07 | 1321121005, 9-100M | 72d | 0d | ELEC ENG [20 h] | 1,325.4 | NELSON R | 1 | 1 |  | BILL M | 08-049 |  |  |  |  |  |  |  |  |  |  |  |  |  |  |
| 1321121015 |  | Fabricate HVPS Lot 1 (3) Original Expenses |  | 243d | 2009-10-08 | 2010-09-30 | 1321121010 | 77d | 58d | TRAVEL | 5,324.09 | NELSON R | 1 | 1 |  | BILL M | 08-049 |  | 10-028 | 10-031 | 10-064 | 10-066 |  |  |  |  |  | 32112A | 10-036 |  |  |
| 1321121020 |  | Vend Fab HVPS Peg Point #1 Design Review |  | 61d | 2010-01-04 | 2010-03-31 | 9-100M FS+59d | 12d | 0d | PROCUREMENT>$50K 69 NO ESCALATION; PROCUREMENT<$50K 60 NO ESCALATION | 71,950 | NELSON R | 1 | 1 |  | BILL M | 08-049 |  | 10-028 | 10-031 | 10-064 | 10-066 |  |  |  |  |  | 32112A | 10-036 |  |  |
| 1321121025 |  | Vend Fab HVPS Peg Point #2 Special Non Stock parts for 10 Systems |  | 146d | 2010-01-04 | 2010-07-30 | 1321121020 FS-61d | 12d | 0d | PROCUREMENT>$50K 69 NO ESCALATION | 170,550 | NELSON R | 1 | 1 |  | BILL M | 08-049 |  | 10-028 | 10-031 | 10-064 | 10-066 |  |  |  |  |  | 32112A | 10-036 |  |  |
| 1321121030 |  | Vend Fab HVPS Peg Point #3 Test 1st Article |  | 230d | 2010-01-04 | 2010-11-30 | 1321121025 FS-146d | 12d | 0d | PROCUREMENT>$50K 69 NO ESCALATION | 33,265 | NELSON R | 1 | 1 |  | BILL M | 08-049 |  | 10-028 | 10-031 | 10-064 | 10-066 |  |  |  |  |  | 32112A | 10-036 |  |  |
| 1321121035 |  | Vend Fab HVPS Peg Point #4 Ship and Accept 1st Article |  | 247d | 2010-01-04 | 2010-12-30 | 1321121030 FS-230d | 12d | 0d | PROCUREMENT>$50K 69 NO ESCALATION | 117,633 | NELSON R | 1 | 1 |  | BILL M | 08-049 |  | 10-028 | 10-031 | 10-064 | 10-066 |  |  |  |  |  | 32112A | 10-036 |  |  |
| 1321121040 |  | Vend Fab HVPS Peg Point #5 Ship and Accept unit #2 |  | 286d | 2010-01-04 | 2011-02-28 | 1321121035 FS-247d | 12d | 0d | PROCUREMENT>$50K 69 NO ESCALATION | 82,633 | NELSON R | 1 | 1 |  | BILL M |  |  | 10-028 | 10-031 | 10-064 | 10-066 |  |  |  |  |  | 32112A | 10-036 |  |  |
| 1321121045 |  | Vend Fab HVPS Peg Point #6 Ship and Accept unit #3 |  | 309d | 2010-01-04 | 2011-03-31 | 1321121040 FS-286d | 45d | 0d | PROCUREMENT>$50K 69 NO ESCALATION | 83,133 | NELSON R | 1 | 1 |  | BILL M |  |  | 10-028 | 10-031 | 10-064 | 10-066 | 12-028F |  | 12-018F | 11-043 | 13-009F | 32112A | 10-036 |  |  |
| 1321121050 |  | Vend Fab HVPS Peg Point #7 Ship and Accept unit #4 |  | 330d | 2010-01-04 | 2011-04-29 | 1321121045 FS-309d | 45d | 0d | PROCUREMENT>$50K 69 NO ESCALATION | 82,633 | NELSON R | 1 | 1 |  | BILL M |  |  | 10-028 | 10-031 | 10-064 | 10-066 | 12-028F |  | 12-018F | 11-043 | 13-009F | 32112A | 10-036 |  |  |
| 1321121055 |  | Vend Fab HVPS Peg Point #8 Ship and Accept unit #5 |  | 351d | 2010-01-04 | 2011-05-31 | 1321121050 FS-330d | 45d | 0d | PROCUREMENT>$50K 69 NO ESCALATION | 82,633 | NELSON R | 1 | 1 |  | BILL M |  |  | 10-028 | 10-031 | 10-064 | 10-066 | 12-028F |  | 12-018F | 11-043 | 13-009F | 32112A | 10-036 |  |  |
| 1321121060 |  | Vend Fab HVPS Peg Point #9 Ship and Accept unit #6 |  | 437d | 2010-01-04 | 2011-09-30 | 1321121055 FS-351d | 270d | 0d | PROCUREMENT>$50K 69 NO ESCALATION | 82,633 | NELSON R | 1 | 1 |  | BILL M |  |  | 10-028 | 10-031 | 10-064 | 10-066 | 12-028F |  | 12-018F | 11-043 | 13-009F | 32112A | 10-036 |  |  |
| 1321121065 |  | Vend Fab HVPS Peg Point #10 Ship and Accept unit #7 |  | 458d | 2010-01-04 | 2011-10-31 | 1321121060 FS-437d | 294d | 0d | PROCUREMENT>$50K 69 NO ESCALATION | 82,633 | NELSON R | 1 | 1 |  | BILL M |  |  | 10-028 | 10-031 | 10-064 | 10-066 | 12-028F |  | 12-018F | 11-043 | 13-009F | 32112A | 10-036 |  |  |
| 1321121070 |  | Vend Fab HVPS Peg Point #11 Ship and Accept unit #8 |  | 478d | 2010-01-04 | 2011-11-30 | 1321121065 FS-458d | 319d | 0d | PROCUREMENT>$50K 69 NO ESCALATION | 82,633 | NELSON R | 1 | 1 |  | BILL M |  |  | 10-028 | 10-031 | 10-064 | 10-066 | 12-028F |  | 12-018F | 11-043 | 13-009F | 32112A | 10-036 |  |  |
| 1321121075 |  | Vend Fab HVPS Peg Point #12 Ship and Accept unit #9 |  | 515d | 2010-01-04 | 2012-01-31 | 1321121070 FS-478d | 337d | 0d | PROCUREMENT>$50K 69 NO ESCALATION | 82,633 | NELSON R | 1 | 1 |  | BILL M |  |  | 10-028 | 10-031 | 10-064 | 10-066 | 12-028F |  | 12-018F | 11-043 | 13-009F | 32112A | 10-036 |  |  |
| 1321121080 |  | Vend Fab HVPS Peg Point #13 Ship and Accept unit #10 |  | 515d | 2010-01-04 | 2012-01-31 | 1321121075 FS-515d | 361d | 0d | PROCUREMENT>$50K 69 NO ESCALATION | 82,633 | NELSON R | 1 | 1 |  | BILL M |  |  | 10-028 | 10-031 | 10-064 | 10-066 | 12-028F |  | 12-018F | 11-043 | 13-009F | 32112A | 10-036 |  |  |
| 1321121085 |  | Re-Baseline Actuals Adjustment |  | 1d | 2013-08-30 | 2013-08-30 | 9-130M FS+227d | 20d |  | PROCUREMENT>$50K 69 NO ESCALATION | 56,293.71 | NELSON R | 1 | 1 |  | BILL M |  |  |  |  |  |  |  |  |  |  |  |  |  | 13-014 | ADJ |

Notes:
- 1321121015: Explanation: CR 08-049 was supposed to be cost neutral but after implementation was an / ~$500 increase, so that amount was deducted from this activity to bring it back / to no cost increase. / After further investigation of CR 08-049 resource rates in P3e it was / determined that the rates were incorrect ($39.78) for some of the Mechanical / Techs on some of the activities that were copied from the what if schedule for / this change request. After recalculating the resource rates the correct rate / ($39.20) was applied to all the Mechanical Techs which made the overall change / request with a lower budget than the previous project. So this activity / procurement over $50k resource was increased by $4,375.80 to ensure a / nuetral cost impact.
- 1321121035: Explanation: Total Price Include $100 for Maintenance & Service / Manual. PMC
- 1321121040: Explanation: Total Price Include $100 for Maintenance & Service / Manual. PMC
- 1321121045: Explanation: Total Price Include $100 for Maintenance & Service / Manual. This Activity Also Includes $500 (2 @ $250 ea) Instruction / Manuals & Required Drawings. PMC
- 1321121050: Explanation: Total Price Include $100 for Maintenance & Service / Manual. PMC
- 1321121055: Explanation: Total Price Include $100 for Maintenance & Service / Manual. PMC
- 1321121060: Explanation: Total Price Include $100 for Maintenance & Service / Manual. PMC
- 1321121065: Explanation: Total Price Include $100 for Maintenance & Service / Manual. PMC
- 1321121070: Explanation: Total Price Include $100 for Maintenance & Service / Manual. PMC
- 1321121075: Explanation: Total Price Include $100 for Maintenance & Service / Manual. PMC
- 1321121080: Explanation: Total Price Include $100 for Maintenance & Service / Manual. PMC

| ID | WBS | Activity | Type | Duration | Start | Finish | Predecessors | Total float | Free float | Resources | Cost | RESP - Responsibility | STRT%COMP for CM EVM | FNSH%COMP for CM EVM | CAM RESPONSIBLE | CR 08-049 | CR 10-028 | CR 10-031 | CR 10-064 | CR 10-066 | CR 12-018 | CR 12-028 | CR 13-009 | Milestone Level | CR 10-056 | CR 11-001 | CR 11-015 | CR 08-052 | CR 10-036 | CR 12-001 | CR 11-043 | CR 13-014 | ReBaseline Actuals Adjustment |
| --- | --- | --- | --- | --- | --- | --- | --- | --- | --- | --- | --- | --- | --- | --- | --- | --- | --- | --- | --- | --- | --- | --- | --- | --- | --- | --- | --- | --- | --- | --- | --- | --- | --- |
|  | 2 | **1.3.2.1.1.2.2 High Power Amplifier** |  |  | 2009-10-01 | 2013-08-30 |  |  |  |  |  |  |  |  |  |  |  |  |  |  |  |  |  |  |  |  |  |  |  |  |  |  |  |
| 1321122000 |  | Order/Receive Components: Aux PS, Cabling |  | 84d | 2009-10-01 | 2010-02-08 | 9-100M | 351d | 0d | PROCUREMENT<$50K 60; ELEC ENG [40 h]; ELEC DES [80 h]; ELEC TECH [80 h] | 305,781.3 | NELSON R | 1 | 1 | BILL M | 08-049 | 10-028 | 10-031 | 10-064 | 10-066 | 12-018F | 12-028F | 13-009F |  |  |  |  |  |  |  |  |  |  |
| 1321122035 |  | Bid HPA Components, Subassemblies |  | 17d | 2009-10-01 | 2009-10-23 | 9-100M | 86d | 0d | MECH TECH [120 h]; ELEC ENG [20 h]; ELEC TECH [80 h] | 9,650.2 | NELSON R | 1 | 1 | BILL M | 08-049 | 10-028 | 10-031 | 10-064 | 10-066 |  |  |  |  |  |  |  |  |  |  |  |  |  |
| 1321122035M |  | Award HPA Components | milestone | 0d | 2009-12-09 | 2009-12-09 | 1321122035 FS+30d | 86d | 16d |  |  | NELSON R | 1 | 1 | BILL M | 08-049 | 10-028 | 10-031 | 10-064 | 10-066 |  |  |  | 6 |  |  |  |  |  |  |  |  |  |
| 1321122020 |  | Bid Solenoid PS (10) |  | 15d | 2010-01-05 | 2010-01-26 | 9-100M FS+60d | 361d | 0d | ELEC ENG [20 h] | 1,325.4 | NELSON R | 1 | 1 | BILL M | 08-049 | 10-028 | 10-031 | 10-064 | 10-066 | 12-018F | 12-028F | 13-009F |  | 10-056 |  |  |  |  |  |  |  |  |
| 1321122040 |  | Fabricate HPA Components |  | 62d | 2010-01-08 | 2010-04-07 | 1321122035M, 9-100M FS+63d | 70d | 0d | MECH TECH [80 h]; PROCUREMENT<$50K 60 | 314,265.94 | NELSON R | 1 | 1 | BILL M | 08-049 | 10-028 | 10-031 | 10-064 | 10-066 |  |  |  |  |  |  |  |  |  |  |  |  |  |
| 1321122050 |  | Fabricate HPA #1 |  | 60d | 2010-01-12 | 2010-04-07 | 1321122040 FS-60d | 70d | 0d | SUPPLIES & MATERIALS; ELEC DES [60 h]; ELEC TECH [80 h]; MECH TECH [480 h] | 34,716.14 | NELSON R | 1 | 1 | BILL M | 08-049 | 10-028 | 10-031 | 10-064 | 10-066 |  |  |  |  |  |  |  |  |  |  |  |  |  |
| 1321122020M |  | Award Solenoid PS | milestone | 0d | 2010-02-03 | 2010-02-03 | 1321122020 FS+5d | 361d | 0d |  |  | NELSON R | 1 | 1 | BILL M | 08-049 | 10-028 | 10-031 | 10-064 | 10-066 | 12-018F | 12-028F | 13-009F | 6 | 10-056 |  |  |  |  |  |  |  |  |
| 1321122025 |  | Fabricate, Receive & Test Solenoid PS (Original Labor) |  | 80d | 2010-02-03 | 2010-05-26 | 1321122020M | 361d | 70d | ELEC ENG [20 h]; ELEC TECH [80 h] | 4,641.4 | NELSON R | 1 | 1 | BILL M | 08-049 | 10-028 | 10-031 | 10-064 | 10-066 | 12-018F | 12-028F | 13-009F |  | 10-056 |  |  |  |  |  |  |  |  |
| 1321122000M |  | Components: Aux PS, Cabling Received | milestone | 0d | 2010-02-09 | 2010-02-09 | 1321122000 | 351d | 0d |  |  | NELSON R | 1 | 1 | BILL M | 08-049 | 10-028 | 10-031 | 10-064 | 10-066 | 12-018F | 12-028F | 13-009F | 6 |  |  |  |  |  |  |  |  |  |
| 1321122005 |  | Fabricate: Aux PS, Cabling FY10 |  | 164d | 2010-02-09 | 2010-09-30 | 1321122000M | 351d | 0d | ELEC TECH [3456.34 h] | 143,265.29 | NELSON R | 1 | 1 | BILL M | 08-049 | 10-028 | 10-031 | 10-064 | 10-066 | 12-018F | 12-028F | 13-009F |  |  | 11-001 |  |  |  |  |  |  |  |
| 1321122045LOE |  | Engineering Oversight FY10 |  | 128d | 2010-04-01 | 2010-09-30 | 9-100M FS+120d, 1321122000M | 434d | 0d | ELEC ENG [201 h] | 13,320.27 | NELSON R | 1 | 1 | BILL M |  | 10-028 | 10-031 | 10-064 | 10-066 | 12-018F | 12-028F | 13-009F |  |  |  |  |  |  |  |  |  |  |
| 1321122010 |  | Test: Aux PS, Cabling FY10 |  | 118d | 2010-04-15 | 2010-09-30 | 1321122005a FS-140d | 351d | 0d | ELEC TECH [424.27 h]; ELEC ENG [13.26 h] | 18,464.73 | NELSON R | 1 | 1 | BILL M | 08-049 | 10-028 | 10-031 | 10-064 | 10-066 | 12-018F | 12-028F | 13-009F |  |  | 11-001 |  |  |  |  |  |  |  |
| 1321122041 |  | Procure AC Power Materiala (208 VAC) |  | 40d | 2010-08-02 | 2010-09-27 | 9-100M FS+205d | 419d | 0d | ELEC ENG [40 h]; SUPPLIES & MATERIALS | 47,650.8 | NELSON R | 1 | 1 | BILL M | 08-049 | 10-028 | 10-031 |  | 10-066 | 12-018F | 12-028F | 13-009F |  |  |  |  |  |  |  |  |  |  |
| 1321122055 |  | Fabricate HPA #2 FY10 |  | 21d | 2010-09-01 | 2010-09-30 | 1321122050 FS+102d | 70d | 0d | MECH TECH [168 h]; ELEC DES [7 h]; ELEC TECH [28 h] | 8,505 | NELSON R | 1 | 1 | BILL M | 08-049 | 10-028 | 10-031 | 10-064 | 10-066 |  |  |  |  |  | 11-001 |  |  |  |  |  |  |  |
| 1321122026 |  | Fabricate Solenoid PS |  | 202d | 2010-09-07 | 2011-06-30 | 1321122025, 9-100M FS+230d | 291d | 0d | PROCUREMENT<$50K 60 NO ESCALATION FY11; PROCUREMENT>$50K 69 NO ESCALATION FY11 | 258,750.68 | NELSON R | 1 | 1 | BILL M |  |  |  | 10-064 | 10-066 | 12-018F | 12-028F | 13-009F |  | 10-056 |  | 11-015 |  |  |  |  |  |  |
| 1321122042 |  | Install RF Zone 208 VAC FY10 |  | 3d | 2010-09-28 | 2010-09-30 | 1321122041 | 419d | 0d | SKLLD TRADE [72 h] | 2,262.24 | NELSON R | 1 | 1 | BILL M | 08-049 | 10-028 | 10-031 |  | 10-066 | 12-018F | 12-028F | 13-009F |  |  | 11-001 |  |  |  |  |  |  |  |
| 1321122060 |  | Fabricate HPA #3 FY10 |  | 1d | 2010-09-30 | 2010-09-30 | 1321122055a FS-40d | 108d | 0d | ELEC DES [0.33 h]; ELEC TECH [1.33 h]; MECH TECH [8 h] | 404.71 | NELSON R | 1 | 1 | BILL M | 08-049 | 10-028 | 10-031 | 10-064 | 10-066 | 12-018F | 12-028F | 13-009F |  |  | 11-001 |  |  |  |  |  |  |  |
| 1321122005a |  | Fabricate: Aux PS, Cabling FY11 |  | 22d | 2010-10-01 | 2010-11-01 | 1321122005 | 351d | 0d | ELEC TECH [463.66 h] | 19,830.74 | NELSON R | 1 | 1 | BILL M | 08-049 | 10-028 | 10-031 | 10-064 | 10-066 | 12-018F | 12-028F | 13-009F |  |  | 11-001 |  |  |  |  |  |  |  |
| 1321122010a |  | Test: Aux PS, Cabling FY11 |  | 60d | 2010-10-01 | 2011-01-04 | 1321122010 | 351d | 60d | ELEC ENG [6.74 h]; ELEC TECH [215.73 h] | 9,687.65 | NELSON R | 1 | 1 | BILL M | 08-049 | 10-028 | 10-031 | 10-064 | 10-066 | 12-018F | 12-028F | 13-009F |  |  | 11-001 |  |  |  |  |  |  |  |
| 1321122042a |  | Install RF Zone 208 VAC FY11 |  | 37d | 2010-10-01 | 2010-11-22 | 1321122042 | 419d | 0d | SKLLD TRADE [888 h] | 28,788.96 | NELSON R | 1 | 1 | BILL M | 08-049 | 10-028 | 10-031 |  | 10-066 | 12-018F | 12-028F | 13-009F |  |  | 11-001 |  |  |  |  |  |  |  |
| 1321122046LOE |  | Engineering Oversight FY11 |  | 248d | 2010-10-01 | 2011-09-30 | 1321122045LOE | 434d | 0d | ELEC ENG [390 h] | 26,668.2 | NELSON R | 1 | 1 | BILL M |  | 10-028 | 10-031 | 10-064 | 10-066 | 12-018F | 12-028F | 13-009F |  |  |  |  |  |  |  |  |  |  |
| 1321122055a |  | Fabricate HPA #2 FY11 |  | 39d | 2010-10-01 | 2010-11-24 | 1321122055 | 70d | 0d | MECH TECH [312 h]; ELEC DES [13 h]; ELEC TECH [52 h] | 16,298.23 | NELSON R | 1 | 1 | BILL M | 08-049 | 10-028 | 10-031 | 10-064 | 10-066 |  |  |  |  |  | 11-001 |  |  |  |  |  |  |  |
| 1321122060a |  | Fabricate HPA #3 FY11 |  | 59d | 2010-10-01 | 2010-12-31 | 1321122060 | 108d | 0d | MECH TECH [472 h]; ELEC DES [19.67 h]; ELEC TECH [78.67 h] | 24,656.61 | NELSON R | 1 | 1 | BILL M | 08-049 | 10-028 | 10-031 | 10-064 | 10-066 | 12-018F | 12-028F | 13-009F |  |  | 11-001 |  |  |  |  |  |  |  |
| 1321122065 |  | Fabricate HPA #4 |  | 60d | 2010-10-28 | 2011-02-01 | 1321122060a FS-40d | 108d | 0d | MECH TECH [480 h]; ELEC TECH [80 h]; ELEC DES [20 h] | 25,074.2 | NELSON R | 1 | 1 | BILL M | 08-049 | 10-028 | 10-031 | 10-064 | 10-066 | 12-018F | 12-028F | 13-009F |  |  |  |  |  |  |  |  |  |  |
| 1321122070 |  | Fabricate HPA #5 Frozen by CR 12-028 |  | 60d | 2010-11-29 | 2011-03-02 | 1321122065 FS-40d | 108d | 0d | ELEC TECH [80 h]; MECH TECH [480 h]; ELEC DES [20 h] | 25,074.2 | NELSON R | 1 | 1 | BILL M | 08-049 | 10-028 | 10-031 | 10-064 | 10-066 | 12-018F | 12-028F | 13-009F |  |  |  |  |  |  |  |  |  |  |
| 1321122100 |  | Install/Test HPA #1 |  | 150d | 2010-12-31 | 2011-08-04 | 132127025b FS-280d, 132127025a FS-280d, 1321122050, 1321121015, 1321121035 | 19d | 0d | ELEC TECH [292 h]; SUPPLIES & MATERIALS; MECH TECH [100 h] | 25,586.12 | NELSON R | 1 | 1 | BILL M | 08-049 | 10-028 | 10-031 | 10-064 | 10-066 |  |  |  |  |  |  |  | 08-052 | 10-036 |  |  |  |  |
| 1321122075 |  | Fabricate HPA #6 Frozen by CR 12-028 |  | 60d | 2011-01-04 | 2011-03-30 | 1321122070 FS-40d | 399d | 0d | ELEC DES [20 h]; ELEC TECH [80 h]; MECH TECH [480 h] | 25,074.2 | NELSON R | 1 | 1 | BILL M | 08-049 | 10-028 | 10-031 | 10-064 | 10-066 | 12-018F | 12-028F | 13-009F |  |  |  |  |  |  |  |  |  |  |
| 1321122015 |  | Install: Aux PS, Cabling FY11 |  | 188d | 2011-01-05 | 2011-09-30 | 3A-03M, 1321122010a FS-60d, 9-110M FS+60d | 291d | 0d | ELEC TECH [519.34 h]; ELEC ENG [10.39 h] | 22,922.64 | NELSON R | 1 | 1 | BILL M | 08-049 | 10-028 | 10-031 | 10-064 | 10-066 | 12-018F | 12-028F | 13-009F |  |  |  |  |  |  | 12-001 |  |  |  |
| 1321122080 |  | Fabricate HPA #7 Frozen by CR 12-028 |  | 60d | 2011-02-02 | 2011-04-27 | 1321122075 FS-40d | 424d | 0d | ELEC DES [20 h]; ELEC TECH [80 h]; MECH TECH [480 h] | 25,074.2 | NELSON R | 1 | 1 | BILL M | 08-049 | 10-028 | 10-031 | 10-064 | 10-066 | 12-018F | 12-028F | 13-009F |  |  |  |  |  |  |  |  |  |  |
| 1321122105 |  | Install/Test HPA #2 |  | 131d | 2011-03-01 | 2011-09-01 | 1321122055a, 1321121040 | 12d | 0d | ELEC TECH [292 h]; MECH TECH [100 h] | 16,795.84 | NELSON R | 1 | 1 | BILL M | 08-049 | 10-028 | 10-031 | 10-064 | 10-066 |  |  |  |  |  |  |  | 08-052 | 10-036 |  |  |  |  |
| 1321122085 |  | Fabricate HPA #8 Frozen by CR 12-028 |  | 60d | 2011-03-03 | 2011-05-25 | 1321122080 FS-40d | 449d | 0d | ELEC DES [20 h]; ELEC TECH [80 h]; MECH TECH [480 h] | 25,074.2 | NELSON R | 1 | 1 | BILL M | 08-049 | 10-028 | 10-031 | 10-064 | 10-066 | 12-018F | 12-028F | 13-009F |  |  |  |  |  |  |  |  |  |  |
| 1321122030 |  | Install Solenoid PS FY11 |  | 144d | 2011-03-10 | 2011-09-30 | 1321122026 FS-80d, 1321122025, 9-110M FS+60d | 291d | 0d | ELEC TECH [72.45 h] | 3,098.69 | NELSON R | 1 | 1 | BILL M | 08-049 | 10-028 | 10-031 | 10-064 | 10-066 | 12-018F | 12-028F | 13-009F |  |  |  | 11-015 |  |  | 12-001 |  |  |  |
| 1321122090 |  | Fabricate HPA #9 Frozen by CR 12-028 |  | 60d | 2011-03-31 | 2011-06-23 | 1321122085 FS-40d | 490d | 0d | MECH TECH [480 h]; ELEC DES [20 h]; ELEC TECH [80 h] | 25,074.2 | NELSON R | 1 | 1 | BILL M | 08-049 | 10-028 | 10-031 | 10-064 | 10-066 | 12-018F | 12-028F | 13-009F |  |  |  |  |  |  |  |  |  |  |
| 1321122110 |  | Install/Test HPA #3 |  | 128d | 2011-04-01 | 2011-09-30 | 1321122060a, 1321121045 | 185d | 0d | ELEC TECH [292 h]; MECH TECH [100 h] | 16,795.84 | NELSON R | 1 | 1 | BILL M | 08-049 | 10-028 | 10-031 | 10-064 | 10-066 |  | 12-028F |  |  |  |  |  | 08-052 | 10-036 |  |  |  |  |
| 1321122095 |  | Fabricate HPA #10 Frozen by CR 12-028 |  | 60d | 2011-04-28 | 2011-07-22 | 1321122090 FS-40d | 494d | 127d | ELEC DES [20 h]; ELEC TECH [80 h]; MECH TECH [480 h] | 25,074.2 | NELSON R | 1 | 1 | BILL M | 08-049 | 10-028 | 10-031 | 10-064 | 10-066 | 12-018F | 12-028F | 13-009F |  |  |  |  |  |  |  |  |  |  |
| 1321122115 |  | Install/Test HPA #4 FY11 |  | 107d | 2011-05-02 | 2011-09-30 | 1321121050, 1321122065 | 175d | 0d | MECH TECH [84.25 h]; ELEC TECH [246.02 h] | 14,150.93 | NELSON R | 1 | 1 | BILL M | 08-049 | 10-028 | 10-031 | 10-064 | 10-066 | 12-018F |  |  |  |  |  |  | 08-052 | 10-036 | 12-001 |  |  |  |
| 1321122120 |  | Install/Test HPA #5 FY11 Frozen by CR 12-028 |  | 86d | 2011-06-01 | 2011-09-30 | 1321121055, 1321122070 | 45d | 0d | MECH TECH [68.25 h]; ELEC TECH [199.3 h] | 11,463.59 | NELSON R | 1 | 1 | BILL M | 08-049 | 10-028 | 10-031 | 10-064 | 10-066 | 12-018F |  | 13-009F |  |  |  |  | 08-052 | 10-036 | 12-001 |  |  |  |
| 1321122015a |  | Install: Aux PS, Cabling FY12 |  | 174d | 2011-10-03 | 2012-06-18 | 1321122015 | 291d | 196d | ELEC TECH [480.66 h]; ELEC ENG [9.61 h] | 21,889.61 | NELSON R | 1 | 1 | BILL M | 08-049 | 10-028 | 10-031 | 10-064 | 10-066 | 12-018F | 12-028F | 13-009F |  |  |  |  |  |  | 12-001 |  |  |  |
| 1321122030a |  | Install Solenoid PS FY12 |  | 174d | 2011-10-03 | 2012-06-18 | 1321122030 | 291d | 196d | ELEC TECH [87.55 h] | 3,863.58 | NELSON R | 1 | 1 | BILL M | 08-049 | 10-028 | 10-031 | 10-064 | 10-066 | 12-018F | 12-028F | 13-009F |  |  |  | 11-015 |  |  | 12-001 |  |  |  |
| 1321122047LOE |  | Engineering Oversight FY12 |  | 31d | 2011-10-03 | 2011-11-14 | 1321122046LOE | 434d | 339d | ELEC ENG [49 h] | 3,457.44 | NELSON R | 1 | 1 | BILL M |  | 10-028 | 10-031 | 10-064 | 10-066 | 12-018F | 12-028F | 13-009F |  |  |  |  |  |  |  |  |  |  |
| 1321122115a |  | Install/Test HPA #4 FY12 |  | 20d | 2011-10-03 | 2011-10-28 | 1321122115 | 175d | 21d | MECH TECH [15.75 h]; ELEC TECH [45.98 h] | 2,729.03 | NELSON R | 1 | 1 | BILL M | 08-049 | 10-028 | 10-031 | 10-064 | 10-066 | 12-018F |  |  |  |  |  |  | 08-052 | 10-036 | 12-001 |  |  |  |
| 1321122120a |  | Install/Test HPA #5 FY12 Frozen by CR 12-028 |  | 40d | 2011-10-03 | 2011-11-29 | 1321122120 | 45d | 0d | MECH TECH [31.75 h]; ELEC TECH [92.7 h] | 5,501.82 | NELSON R | 1 | 1 | BILL M | 08-049 | 10-028 | 10-031 | 10-064 | 10-066 | 12-018F |  | 13-009F |  |  |  |  | 08-052 | 10-036 | 12-001 |  |  |  |
| 1321122125 |  | Install/Test HPA #6 Frozen by CR 12-028 |  | 98d | 2011-10-03 | 2012-02-29 | 1321122075, 1321121060 | 270d | 219d | MECH TECH [53.26 h]; ELEC TECH [155.52 h] | 9,229.97 | NELSON R | 1 | 1 | BILL M | 08-049 | 10-028 | 10-031 | 10-064 | 10-066 | 12-018F | 12-028 | 13-009F |  |  |  |  | 08-052 | 10-036 |  | 11-043 |  |  |
| 1321122130 |  | Install/Test HPA #7 Frozen by CR 12-028 |  | 77d | 2011-11-01 | 2012-02-29 | 1321122080, 1321121065 | 294d | 233d | MECH TECH [41.85 h]; ELEC TECH [122.2 h] | 7,252.5 | NELSON R | 1 | 1 | BILL M | 08-049 | 10-028 | 10-031 | 10-064 | 10-066 | 12-018F | 12-028 | 13-009F |  |  |  |  | 08-052 | 10-036 |  | 11-043 |  |  |
| 1321122135 |  | Install/Test HPA #8 Frozen by CR 12-028 |  | 57d | 2011-12-01 | 2012-02-29 | 1321122085, 1321121070 | 319d | 246d | ELEC TECH [91.96 h]; MECH TECH [31.49 h] | 5,457.61 | NELSON R | 1 | 1 | BILL M | 08-049 | 10-028 | 10-031 | 10-064 | 10-066 | 12-018F | 12-028 | 13-009F |  |  |  |  | 08-052 | 10-036 |  | 11-043 |  |  |
| 1321122140 |  | Install/Test HPA #9 Frozen by CR 12-028 |  | 20d | 2012-02-01 | 2012-02-29 | 1321122090, 1321121075 | 343d | 259d | MECH TECH [11.11 h]; ELEC TECH [32.44 h] | 1,925.31 | NELSON R | 1 | 1 | BILL M | 08-049 | 10-028 | 10-031 | 10-064 | 10-066 | 12-018F | 12-028 | 13-009F |  |  |  |  | 08-052 | 10-036 |  | 11-043 |  |  |
| 1321122145 |  | Install/Test HPA #10 Frozen by CR 12-028 |  | 20d | 2012-02-01 | 2012-02-29 | 1321121080, 1321122095 | 367d | 272d | ELEC TECH [32.63 h]; MECH TECH [11.17 h] | 1,936.35 | NELSON R | 1 | 1 | BILL M | 08-049 | 10-028 | 10-031 | 10-064 | 10-066 | 12-018F | 12-028 | 13-009F |  |  |  |  | 08-052 | 10-036 |  | 11-043 |  |  |
| 1321122210 |  | Reverse Entry Per CR 12-028 |  | 15d | 2012-03-05 | 2012-03-23 | 9-120M FS+100d | 132d |  | ELEC TECH [-800 h]; MECH TECH [-1600 h]; ELEC DES [-61.36 h] | -109,507.29 | NELSON R | 1 | 1 | BILL M | 08-049 | 10-028 | 10-031 | 10-064 | 10-066 | 12-018F | 12-028 |  |  |  |  |  | 08-052 | 10-036 |  | 11-043 |  |  |
| 1321122150 |  | Fabricate HPA #5 Revised per CR 12-028 |  | 25d | 2012-10-01 | 2012-11-02 | 1321122065 FS-40d, 132127035 FS-99d, 132127030 FS-91d, 9-130M | 51d | 0d | ELEC TECH [40 h]; MECH TECH [240 h]; ELEC DES [10 h] | 13,349.2 | NELSON R | 1 | 1 | BILL M | 08-049 | 10-028 | 10-031 | 10-064 | 10-066 | 12-018F | 12-028 |  |  |  |  |  |  |  |  |  |  |  |
| 1321122155 |  | Fabricate HPA #6 Revised per CR 12-028 |  | 25d | 2012-10-22 | 2012-11-27 | 1321122150 FS-10d | 55d | 0d | MECH TECH [240 h]; ELEC DES [10 h]; ELEC TECH [40 h] | 13,349.2 | NELSON R | 1 | 1 | BILL M | 08-049 | 10-028 | 10-031 | 10-064 | 10-066 | 12-018F | 12-028 | 13-009F |  |  |  |  |  |  |  |  |  |  |
| 1321122160 |  | Fabricate HPA #7 Revised per CR 12-028 |  | 25d | 2012-11-12 | 2012-12-18 | 1321122155 FS-10d | 64d | 0d | ELEC DES [10 h]; ELEC TECH [40 h]; MECH TECH [240 h] | 13,349.2 | NELSON R | 1 | 1 | BILL M | 08-049 | 10-028 | 10-031 | 10-064 | 10-066 | 12-018F | 12-028 | 13-009F |  |  |  |  |  |  |  |  |  |  |
| 1321122180 |  | Install/Test HPA #5 Revised per CR 12-028 |  | 26d | 2012-11-13 | 2012-12-20 | 1321122150 FS+6d, 1321121055 | 51d | 0d | MECH TECH [100 h]; ELEC TECH [292 h] | 17,883.68 | NELSON R | 1 | 1 | BILL M | 08-049 | 10-028 | 10-031 | 10-064 | 10-066 | 12-018F | 12-028 | 13-009F |  |  |  |  | 08-052 | 10-036 | 12-001 |  |  |  |
| 1321122185 |  | Install/Test HPA #6 Revised per CR 12-028 |  | 26d | 2012-12-04 | 2013-01-16 | 1321122155, 1321122180 FS-13d, 1321121060 | 51d | 0d | MECH TECH [100 h]; ELEC TECH [292 h] | 17,883.68 | NELSON R | 1 | 1 | BILL M | 08-049 | 10-028 | 10-031 | 10-064 | 10-066 | 12-018F | 12-028 | 13-009F |  |  |  |  | 08-052 | 10-036 |  | 11-043 |  |  |
| 1321122165 |  | Fabricate HPA #8 Revised per CR 12-028 |  | 25d | 2012-12-05 | 2013-01-16 | 1321122160 FS-10d | 74d | 0d | MECH TECH [240 h]; ELEC DES [10 h]; ELEC TECH [40 h] | 13,349.2 | NELSON R | 1 | 1 | BILL M | 08-049 | 10-028 | 10-031 | 10-064 | 10-066 | 12-018F | 12-028 | 13-009F |  |  |  |  |  |  |  |  |  |  |
| 1321122170 |  | Fabricate HPA #9 Revised per CR 12-028 |  | 25d | 2012-12-19 | 2013-01-31 | 1321122165 FS-15d | 88d | 0d | MECH TECH [240 h]; ELEC DES [10 h]; ELEC TECH [40 h] | 13,349.2 | NELSON R | 1 | 1 | BILL M | 08-049 | 10-028 | 10-031 | 10-064 | 10-066 | 12-018F | 12-028 | 13-009F |  |  |  |  |  |  |  |  |  |  |
| 1321122190 |  | Install/Test HPA #7 Revised per CR 12-028 |  | 26d | 2012-12-31 | 2013-02-06 | 1321122185 FS-12d, 1321121065, 1321122160 | 61d | 0d | ELEC TECH [292 h]; MECH TECH [100 h] | 17,883.68 | NELSON R | 1 | 1 | BILL M | 08-049 | 10-028 | 10-031 | 10-064 | 10-066 | 12-018F | 12-028 | 13-009F |  |  |  |  | 08-052 | 10-036 |  | 11-043 |  |  |
| 1321122175 |  | Fabricate HPA #10 Revised per CR 12-028 |  | 25d | 2013-01-10 | 2013-02-14 | 1321122170 FS-15d | 102d | 7d | ELEC TECH [40 h]; MECH TECH [240 h]; ELEC DES [10 h] | 13,349.2 | NELSON R | 1 | 1 | BILL M | 08-049 | 10-028 | 10-031 | 10-064 | 10-066 | 12-018F | 12-028 | 13-009F |  |  |  |  |  |  |  |  |  |  |
| 1321122195 |  | Install/Test HPA #8 Revised per CR 12-028 |  | 26d | 2013-01-18 | 2013-02-26 | 1321121070, 1321122190 FS-13d, 1321122165 | 73d | 0d | ELEC TECH [292 h]; MECH TECH [100 h] | 17,883.68 | NELSON R | 1 | 1 | BILL M | 08-049 | 10-028 | 10-031 | 10-064 | 10-066 | 12-018F | 12-028 | 13-009F |  |  |  |  | 08-052 | 10-036 |  | 11-043 |  |  |
| 1321122200 |  | Install/Test HPA #9 Revised per CR 12-028 |  | 26d | 2013-02-07 | 2013-03-15 | 1321122195 FS-13d, 1321122170, 1321121075 | 84d | 0d | MECH TECH [100 h]; ELEC TECH [292 h] | 17,883.68 | NELSON R | 1 | 1 | BILL M | 08-049 | 10-028 | 10-031 | 10-064 | 10-066 | 12-018F | 12-028 | 13-009F |  |  |  |  | 08-052 | 10-036 |  | 11-043 |  |  |
| 1321122205 |  | Install/Test HPA #10 Revised per CR 12-028 |  | 26d | 2013-02-27 | 2013-04-03 | 1321122200 FS-13d, 1321122175, 1321121080 | 95d | 0d | ELEC TECH [146 h]; MECH TECH [50 h] | 8,941.84 | NELSON R | 1 | 1 | BILL M | 08-049 | 10-028 | 10-031 | 10-064 | 10-066 | 12-018F | 12-028 | 13-009F |  |  |  |  | 08-052 | 10-036 |  | 11-043 |  |  |
| 1321122215 |  | Re-Baseline Actuals Adjustment |  | 1d | 2013-08-30 | 2013-08-30 | 9-130M FS+227d | 20d |  | PROCUREMENT>$50K 69 NO ESCALATION | -18,680.8 | NELSON R | 1 | 1 | BILL M |  |  |  |  |  |  |  |  |  |  |  |  |  |  |  |  | 13-014 | ADJ |

| ID | WBS | Activity | Type | Duration | Start | Finish | Predecessors | Total float | Free float | Calendar | Resources | Cost | RESP - Responsibility | STRT%COMP for CM EVM | FNSH%COMP for CM EVM | CAM RESPONSIBLE | CR 12-028 | Advance Purchase Plan > 500K | 12 GEV MAJOR PROCUREMENT CATAGORY | CR 10-035 | CR 08-016 | CR 09-012 | CR 11-001 | CR 10-028 | CR 10-031 | CR 10-064 | CR 10-066 | CR 12-018 | Milestone Level | CR 12-001 | CR 12-053 | CR 13-003 | CR 13-014 | ReBaseline Actuals Adjustment | Original Activity ID Rebaseline | BOE Labor | BOE Expenses | CR 13-015 | Post Rebaseline |
| --- | --- | --- | --- | --- | --- | --- | --- | --- | --- | --- | --- | --- | --- | --- | --- | --- | --- | --- | --- | --- | --- | --- | --- | --- | --- | --- | --- | --- | --- | --- | --- | --- | --- | --- | --- | --- | --- | --- | --- |
|  | 3 | **1.3.2.1.1.3 WAVEGUIDE COMPONENTS** |  |  | 2009-08-19 | 2013-09-06 |  |  |  |  |  |  |  |  |  |  |  |  |  |  |  |  |  |  |  |  |  |  |  |  |  |  |  |  |  |  |  |  |  |
| 132113000 |  | Final Tweaking of Waveguide Layout (Klystron specific) (WVGUIDE COMPON) FY09 |  | 40d | 2009-08-19 | 2009-10-14 | 1212113090M, 132111035 FS+2d, 1212113170 | 188d | 0d |  | SUPPLIES & MATERIALS; ELEC ENG [80 h]; MECH DES [80 h] | 12,560.15 | NELSON R | 1 | 1 | BILL M | 12-028F |  |  |  |  |  |  |  |  |  |  |  |  |  |  |  |  |  |  |  |  |  |  |
| 132113005 |  | Release Prcrmnt: Circulators (WVGUIDE COMPON) |  | 10d | 2009-10-15 | 2009-10-28 | 132113000 | 237d | 0d |  | ELEC ENG [8 h] | 530.16 | NELSON R | 1 | 1 | BILL M | 12-028F |  |  |  |  |  |  |  |  |  |  |  |  |  |  |  |  |  |  |  |  |  |  |
| 132113010 |  | Release Prcrmnt: HOM Filter (WVGUIDE COMPON) |  | 10d | 2009-10-15 | 2009-10-28 | 132113000 | 188d | 0d |  | ELEC ENG [8 h] | 530.16 | NELSON R | 1 | 1 | BILL M | 12-028F |  |  |  |  |  |  |  |  |  |  |  |  |  |  |  |  |  |  |  |  |  |  |
| 132113015 |  | Release Prcrmnt: Waveguide Parts (WVGUIDE COMPON) |  | 10d | 2009-10-15 | 2009-10-28 | 132113000 | 188d | 0d |  | ELEC ENG [8 h] | 530.16 | NELSON R | 1 | 1 | BILL M | 12-028F |  |  |  |  |  |  |  |  |  |  |  |  |  |  |  |  |  |  |  |  |  |  |
| 132113020 |  | Release Prcrmnt: Special Waveguide (WVGUIDE COMPON) |  | 10d | 2009-10-15 | 2009-10-28 | 132113000 | 188d | 0d |  | ELEC ENG [8 h] | 530.16 | NELSON R | 1 | 1 | BILL M | 12-028F |  |  |  |  |  |  |  |  |  |  |  |  |  |  |  |  |  |  |  |  |  |  |
| 132113025 |  | Receive Responses, Evaluate, Award: Circulators (WVGUIDE COMPON) |  | 30d | 2009-10-29 | 2009-12-11 | 132113005 | 237d | 9d |  | ELEC ENG [8 h] | 530.16 | NELSON R | 1 | 1 | BILL M | 12-028F |  |  |  |  |  |  |  |  |  |  |  |  |  |  |  |  |  |  |  |  |  |  |
| 132113030 |  | Receive Responses, Evaluate, Award: HOM Filters (WVGUIDE COMPON) |  | 30d | 2009-10-29 | 2009-12-11 | 132113010 | 188d | 0d |  | ELEC ENG [8 h] | 530.16 | NELSON R | 1 | 1 | BILL M | 12-028F |  |  |  |  |  |  |  |  |  |  |  |  |  |  |  |  |  |  |  |  |  |  |
| 132113035 |  | Receive Responses, Evaluate, Award: Special Waveguide (WVGUIDE COMPON) |  | 30d | 2009-10-29 | 2009-12-11 | 132113015 | 188d | 0d |  | ELEC ENG [8 h] | 530.16 | NELSON R | 1 | 1 | BILL M | 12-028F |  |  |  |  |  |  |  |  |  |  |  |  |  |  |  |  |  |  |  |  |  |  |
| 132113040 |  | Receive Responses, Evaluate, Award: Waveguide Parts (WVGUIDE COMPON) |  | 30d | 2009-10-29 | 2009-12-11 | 132113020 | 188d | 0d |  | ELEC ENG [8 h] | 530.16 | NELSON R | 1 | 1 | BILL M | 12-028F |  |  |  |  |  |  |  |  |  |  |  |  |  |  |  |  |  |  |  |  |  |  |
| 132113050 |  | Receive First HOMs (manufacturing delay) (WVGUIDE COMPON) |  | 60d | 2009-12-14 | 2010-03-17 | 132113030 | 188d | 0d |  |  |  | NELSON R | 1 | 1 | BILL M | 12-028F |  |  |  |  |  |  |  |  |  |  |  |  |  |  |  |  |  |  |  |  |  |  |
| 132113055 |  | Receive First Special Waveguide (mfr delay) (WVGUIDE COMPON) |  | 60d | 2009-12-14 | 2010-03-17 | 132113035 | 188d | 0d |  |  |  | NELSON R | 1 | 1 | BILL M | 12-028F |  |  |  |  |  |  |  |  |  |  |  |  |  |  |  |  |  |  |  |  |  |  |
| 132113060 |  | Receive First Waveguide Parts (mfr delay) (WVGUIDE COMPON) |  | 60d | 2009-12-14 | 2010-03-17 | 132113040 | 188d | 0d |  |  |  | NELSON R | 1 | 1 | BILL M | 12-028F |  |  |  |  |  |  |  |  |  |  |  |  |  |  |  |  |  |  |  |  |  |  |
| 132113045 |  | Vend Fab Circulators Peg Point #1 Design Review |  | 33d | 2010-01-04 | 2010-02-19 | 9-100M FS+59d, 132113025 | 228d | 0d |  |  |  | NELSON R | 1 | 1 | BILL M | 12-028F | APP | 32113 | 10-035 |  |  |  |  |  |  |  |  |  |  |  |  |  |  |  |  |  |  |  |
| 132113045A |  | Vend Fab Circulators Peg Point #2 1st Article Testing |  | 75d | 2010-01-04 | 2010-04-20 | 132113045 FS-33d | 228d | 0d |  |  |  | NELSON R | 1 | 1 | BILL M | 12-028F | APP | 32113 | 10-035 |  |  |  |  |  |  |  |  |  |  |  |  |  |  |  |  |  |  |  |
| 132113045B |  | Vend Fab Circulators Peg Point #3 1st Article Delivery and Acceptance |  | 103d | 2010-01-04 | 2010-05-28 | 132113045A FS-75d | 228d | 0d |  | PROCUREMENT<$50K 60 NO ESCALATION | 8,150 | NELSON R | 1 | 1 | BILL M | 12-028F | APP | 32113 | 10-035 |  |  |  |  |  |  |  |  |  |  |  |  |  |  |  |  |  |  |  |
| 132113045C |  | Vend Fab Circulators Peg Point #4 Units 2-20 Delivery and Acceptance |  | 125d | 2010-01-04 | 2010-06-30 | 132113045B FS-103d | 228d | 0d |  | PROCUREMENT<$50K 60 NO ESCALATION; PROCUREMENT>$50K 69 NO ESCALATION | 154,850 | NELSON R | 1 | 1 | BILL M | 12-028F | APP | 32113 | 10-035 |  |  |  |  |  |  |  |  |  |  |  |  |  |  |  |  |  |  |  |
| 132113045D |  | Vend Fab Circulators Peg Point #5 Units 21-40 Delivery and Acceptance |  | 146d | 2010-01-04 | 2010-07-30 | 132113045C FS-125d | 228d | 0d |  | PROCUREMENT>$50K 69 NO ESCALATION | 163,000 | NELSON R | 1 | 1 | BILL M | 12-028F | APP | 32113 | 10-035 |  |  |  |  |  |  |  |  |  |  |  |  |  |  |  |  |  |  |  |
| 132113045F |  | Vend Fab Circulators Peg Point #6 Units 41-60 Delivery and Acceptance |  | 168d | 2010-01-04 | 2010-08-31 | 132113045D FS-146d | 228d | 0d |  | PROCUREMENT>$50K 69 NO ESCALATION | 163,000 | NELSON R | 1 | 1 | BILL M | 12-028F | APP | 32113 | 10-035 |  |  |  |  |  |  |  |  |  |  |  |  |  |  |  |  |  |  |  |
| 132113045G |  | Vend Fab Circulators Peg Point #7 Units 61-84 Delivery and Acceptance |  | 189d | 2010-01-04 | 2010-09-30 | 132113045F FS-168d | 228d | 60d |  | PROCUREMENT>$50K 69 NO ESCALATION | 195,600 | NELSON R | 1 | 1 | BILL M | 12-028F | APP | 32113 | 10-035 |  |  |  |  |  |  |  |  |  |  |  |  |  |  |  |  |  |  |  |
| 132113065 |  | Receive,Test,Install Waveguide Compnts (P-#1, 4 zones) (WVGUIDE COMPON) Labor FY10 |  | 138d | 2010-03-18 | 2010-09-30 | 132113060, 132113050, 32-03M, 132113055 | 188d | 0d |  | SUPPLIES & MATERIALS; MECH TECH [558.2 h]; ELEC ENG [12.4 h]; ELEC TECH [558.2 h]; ELEC DES [155.06 h] | 59,009.24 | NELSON R | 1 | 1 | BILL M | 12-028F | APP | 32113 | 10-035 | 08-016 | 09-012 | 11-001 |  |  |  |  |  |  |  |  |  |  |  |  |  |  |  |  |
| 132113065b |  | Receive,Test,Install Waveguide Compnts (P-#1, 4 zones) (WVGUIDE COMPON) Procurement |  | 178d | 2010-03-18 | 2010-11-29 | 132113060, 132113055, 32-03M, 132113050 | 188d | 0d |  | PROCUREMENT>$50K 69 NO ESCALATION FY11 | 352,748.73 | NELSON R | 1 | 1 | BILL M | 12-028F | APP | 32113 | 10-035 | 08-016 | 09-012 | 11-001 |  |  |  |  |  |  |  |  |  |  |  |  |  |  |  |  |
| 132113100 |  | Develop and Release Bid Package (40) HOM Filter (WVGUIDE COMPON) |  | 20d | 2010-05-04 | 2010-06-01 | 9-100M FS+143d | 207d | 0d |  | ELEC ENG [32 h] | 2,120.64 | NELSON R | 1 | 1 | BILL M | 12-028F |  |  |  |  |  |  | 10-028 | 10-031 | 10-064 | 10-066 | 12-018F |  |  |  |  |  |  |  |  |  |  |  |
| 132113105 |  | Receive Responses, Evaluate, Award: (40) HOM Filters (WVGUIDE COMPON) |  | 50d | 2010-06-02 | 2010-08-11 | 132113100 | 207d | 0d |  | ELEC ENG [40 h] | 2,650.8 | NELSON R | 1 | 1 | BILL M | 12-028F |  |  |  |  |  |  | 10-028 | 10-031 | 10-064 | 10-066 | 12-018F |  |  |  |  |  |  |  |  |  |  |  |
| 132113065a |  | Receive,Test,Install Waveguide Compnts (P-#1, 4 zones) (WVGUIDE COMPON) Labor FY11 |  | 40d | 2010-10-01 | 2010-11-29 | 132113065 | 188d | 0d |  | ELEC ENG [3.6 h]; ELEC TECH [161.8 h]; ELEC DES [44.94 h]; SUPPLIES & MATERIALS; MECH TECH [161.8 h] | 17,649.39 | NELSON R | 1 | 1 | BILL M | 12-028F | APP | 32113 | 10-035 | 08-016 | 09-012 | 11-001 |  |  |  |  |  |  |  |  |  |  |  |  |  |  |  |  |
| 132113110 |  | Vend Fab (40) HOMs (manufacturing delay) (WVGUIDE COMPON) |  | 198d | 2010-11-05 | 2011-08-25 | 132113105 FS+60d | 207d | 0d |  | PROCUREMENT>$50K 69; PROCUREMENT<$50K 60 | 309,570 | NELSON R | 1 | 1 | BILL M | 12-028F |  |  |  |  |  |  | 10-028 | 10-031 | 10-064 | 10-066 | 12-018F |  |  |  |  |  |  |  |  |  |  |  |
| 132113070M |  | End P-#1 Waveguide Installtn (WVGUIDE COMPON) | milestone | 0d | 2010-11-29 | 2010-11-29 | 132113065a, 132113065b | 188d | 20d |  |  |  | NELSON R | 1 | 1 | BILL M | 12-028F |  |  |  |  |  |  |  |  |  |  |  | 6 |  |  |  |  |  |  |  |  |  |  |
| 132113075 |  | Receive,Test,Install Waveguide Compnts (P-#2, 4 zones) (WVGUIDE COMPON) Labor FY11 |  | 188d | 2011-01-05 | 2011-09-30 | 132113070M, 9-110M FS+60d, 132113045G | 168d | 0d |  | ELEC DES [153.47 h]; MECH TECH [552.49 h]; SUPPLIES & MATERIALS; ELEC TECH [552.49 h] | 59,428.41 | NELSON R | 1 | 1 | BILL M | 12-028F | APP | 32113 | 10-035 | 08-016 | 09-012 |  |  |  |  |  |  |  | 12-001 |  |  |  |  |  |  |  |  |  |
| 132113075b |  | Receive,Test,Install Waveguide Compnts (P-#2, 4 zones) (WVGUIDE COMPON) Procurement |  | 245d | 2011-01-05 | 2011-12-29 | 9-110M FS+60d, 132113045G, 132113070M | 168d | 0d |  | PROCUREMENT>$50K 69 NO ESCALATION FY12; PROCUREMENT<$50K 60 NO ESCALATION FY12 | 365,213.48 | NELSON R | 1 | 1 | BILL M | 12-028F | APP | 32113 | 10-035 | 08-016 | 09-012 |  |  |  |  |  |  |  | 12-001 |  |  |  |  |  |  |  |  |  |
| 132113115 |  | Receive and Inspect: (40) HOM Filters (WVGUIDE COMPON) |  | 148d | 2011-02-15 | 2011-09-14 | 132113110 FS-135d | 207d | 172d |  | ELEC TECH [80 h]; ELEC ENG [40 h] | 6,156.8 | NELSON R | 1 | 1 | BILL M | 12-028F |  |  |  |  |  |  | 10-028 | 10-031 | 10-064 | 10-066 | 12-018F |  |  |  |  |  |  |  |  |  |  |  |
| 132113075a |  | Receive,Test,Install Waveguide Compnts (P-#2, 4 zones) (WVGUIDE COMPON) Labor FY12 |  | 57d | 2011-10-03 | 2011-12-29 | 132113075 | 168d | 0d |  | ELEC DES [46.53 h]; MECH TECH [167.51 h]; SUPPLIES & MATERIALS; ELEC TECH [167.51 h] | 18,591.44 | NELSON R | 1 | 1 | BILL M | 12-028F | APP | 32113 | 10-035 | 08-016 | 09-012 |  |  |  |  |  |  |  | 12-001 |  |  |  |  |  |  |  |  |  |
| 132113080M |  | End P-#2 Waveguide Installtn (WVGUIDE COMPON) | milestone | 0d | 2012-04-24 | 2012-04-24 | 132113075a FS+80d, 132113075b FS+80d | 168d | 0d |  |  |  | NELSON R | 1 | 1 | BILL M | 12-028F |  |  |  |  |  |  |  |  |  |  |  | 6 |  |  |  |  |  |  |  |  |  |  |
| 132113085 |  | Receive,Test,Install Waveguide Compnts (P-#3, 2 zones) (WVGUIDE COMPON) FY12 |  | 110d | 2012-04-25 | 2012-09-28 | 132113080M | 168d | 0d |  | ELEC DES [66 h]; ELEC TECH [198 h]; MECH TECH [198 h]; SUPPLIES & MATERIALS | 22,196.14 | NELSON R | 1 | 1 | BILL M | 12-028F | APP | 32113 |  | 08-016 | 09-012 |  |  |  |  |  |  |  |  | 12-053 |  |  |  |  |  |  |  |  |
| 132113085b |  | Receive,Test,Install Waveguide Compnts (P-#3, 2 zones) (WVGUIDE COMPON) Procurement |  | 200d | 2012-04-25 | 2013-02-14 | 132113080M | 168d | 0d |  | PROCUREMENT>$50K 69 NO ESCALATION FY13; PROCUREMENT<$50K 60 NO ESCALATION FY13 | 296,795.4 | NELSON R | 1 | 1 | BILL M | 12-028F | APP | 32113 |  | 08-016 | 09-012 |  |  |  |  |  |  |  |  | 12-053 |  |  |  |  |  |  |  |  |
| 132113085a |  | Receive,Test,Install Waveguide Compnts (P-#3, 2 zones) (WVGUIDE COMPON) FY13 |  | 90d | 2012-10-01 | 2013-02-14 | 132113085 | 168d | 0d |  | ELEC DES [54 h]; ELEC TECH [162 h]; MECH TECH [162 h]; SUPPLIES & MATERIALS | 18,740.47 | NELSON R | 1 | 1 | BILL M | 12-028F | APP | 32113 |  | 08-016 | 09-012 |  |  |  |  |  |  |  |  | 12-053 |  |  |  |  |  |  |  |  |
| 132113130 |  | Klystron:Modify 20 tubes for body current problems |  | 13d | 2012-11-05 | 2012-11-21 | 9-130M FS+25d | 52d | 0d |  | ELEC TECH [40 h]; ELEC ENG [16 h] | 2,986.56 | NELSON R | 1 | 1 | BILL M | 12-028F |  |  |  |  |  |  | 10-028 | 10-031 | 10-064 | 10-066 | 12-018F |  |  |  | 13-003 |  |  |  |  |  |  |  |
| 132113120 |  | Remove SL Circulators for Repair |  | 58d | 2013-01-14 | 2013-04-05 | 9-130M FS+67d | 73d | 0d |  | ELEC TECH [140 h]; ELEC ENG [8 h] | 6,958.08 | NELSON R | 1 | 1 | BILL M | 12-028F |  |  |  |  |  |  | 10-028 | 10-031 | 10-064 | 10-066 | 12-018F |  |  |  | 13-003 |  |  |  |  |  |  |  |
| 132113090M |  | Waveguide Installtn Comp (WVGUIDE COMPON) | milestone | 0d | 2013-02-14 | 2013-02-14 | 132113085a, 132113085b | 168d | 33d |  |  |  | NELSON R | 1 | 1 | BILL M | 12-028F |  |  |  |  |  |  |  |  |  |  |  | 6 |  |  |  |  |  |  |  |  |  |  |
| 132113125 |  | Test and Reinstall SL Circulators |  | 75d | 2013-03-18 | 2013-07-01 | 132113120 FS-15d | 73d | 38d |  | ELEC TECH [220 h]; ELEC ENG [72 h] | 15,261.12 | NELSON R | 1 | 1 | BILL M | 12-028F |  |  |  |  |  |  | 10-028 | 10-031 | 10-064 | 10-066 | 12-018F |  |  |  | 13-003 |  |  |  |  |  |  |  |
| 132113135 |  | Klystrons: Retune 20 tubes after Mods |  | 75d | 2013-03-18 | 2013-07-01 | 132113130 FS+72d | 52d |  |  | ELEC TECH [40 h]; ELEC ENG [64 h] | 6,481.44 | NELSON R | 1 | 1 | BILL M | 12-028F |  |  |  |  |  |  | 10-028 | 10-031 | 10-064 | 10-066 | 12-018F |  |  |  | 13-003 |  |  |  |  |  |  |  |
| 132113140 |  | Re-Baseline Actuals Adjustment |  | 1d | 2013-08-30 | 2013-08-30 | 9-130M FS+227d | 20d |  |  | PROCUREMENT>$50K 69 NO ESCALATION | -623,864.83 | NELSON R | 1 | 1 | BILL M |  |  |  |  |  |  |  |  |  |  |  |  |  |  |  |  | 13-014 | ADJ |  |  |  |  |  |
| 232113125 |  | Test and Reinstall SL Circulators |  | 4d | 2013-09-03 | 2013-09-06 | 9-130M FS+228d | 71d | 43d | 8/5 M-F w/JLAB Holidays ReBaseline | ELEC TECH [11 h]; ELEC ENG [3.6 h] | 763.06 | NELSON R | 1 | 1 | BILL M | 12-028F |  |  |  |  |  |  | 10-028 | 10-031 | 10-064 | 10-066 | 12-018F |  |  |  | 13-003 |  |  | 232113125 | PE | PE | 13-015 | PR |

Notes:
- 132113065: Entry Criteria: Ext Pred: Machine in Maintenance SAD for access
- 132113065b: Entry Criteria: Ext Pred: Machine in Maintenance SAD for access
- 132113100: Entry Criteria: Ext Pred: Machine in Maint SAD for access
- 132113105: Entry Criteria: Ext Pred: Machine in Maint SAD for access
- 132113065a: Entry Criteria: Ext Pred: Machine in Maintenance SAD for access
- 132113110: Entry Criteria: Ext Pred: Machine in Maint SAD for access
- 132113075: Entry Criteria: Ext Pred: Machine in Maint SAD for access
- 132113075b: Entry Criteria: Ext Pred: Machine in Maint SAD for access
- 132113115: Entry Criteria: Ext Pred: Machine in Maint SAD for access
- 132113075a: Entry Criteria: Ext Pred: Machine in Maint SAD for access
- 132113085: Entry Criteria: Ext Pred: Machine in Maint SAD for access
- 132113085b: Entry Criteria: Ext Pred: Machine in Maint SAD for access
- 132113085a: Entry Criteria: Ext Pred: Machine in Maint SAD for access
- 132113130: Entry Criteria: Ext Pred: Machine in Maint SAD for access
- 132113120: Entry Criteria: Ext Pred: Machine in Maint SAD for access
- 132113125: Entry Criteria: Ext Pred: Machine in Maint SAD for access
- 132113135: Entry Criteria: Ext Pred: Machine in Maint SAD for access
- 232113125: Entry Criteria: Ext Pred: Machine in Maint SAD for access

| ID | WBS | Activity | Type | Duration | Start | Finish | Predecessors | Total float | Free float | Resources | Cost | RESP - Responsibility | STRT%COMP for CM EVM | FNSH%COMP for CM EVM | CR 08-009 | CAM RESPONSIBLE | CR 09-012 | CR 10-031 | CR 10-064 | CR 10-066 | Inter Project Link (IPL) | Milestone Level | CR 08-016 | CR 10-028 | CR 11-001 | CR 12-028 | CR 12-001 | CR 12-018 | CR 13-009 | CR 13-014 | ReBaseline Actuals Adjustment |
| --- | --- | --- | --- | --- | --- | --- | --- | --- | --- | --- | --- | --- | --- | --- | --- | --- | --- | --- | --- | --- | --- | --- | --- | --- | --- | --- | --- | --- | --- | --- | --- |
|  | 2 | **1.3.2.1.2 CONTROL** |  |  | 2009-10-01 | 2013-08-30 |  |  |  |  |  |  |  |  |  |  |  |  |  |  |  |  |  |  |  |  |  |  |  |  |  |
|  | 1 | **1.3.2.1.2.1 FIELD CONTROL (RF Items - All LLRF Labor)** |  |  | 2009-10-01 | 2013-08-30 |  |  |  |  |  |  |  |  |  |  |  |  |  |  |  |  |  |  |  |  |  |  |  |  |  |
| 132121000 |  | RF & Digital Bd Bid & Award (FIELD Control) |  | 60d | 2009-10-01 | 2010-01-04 | 1212121170, 9-100M, 1212121145M, 1212121095 | 74d | 0d | TRAVEL; ELEC ENG [200 h]; ELEC DES [160 h]; OFFICE [40 h] | 25,213.15 | HOVATER C | 1 | 1 | 08-009 | BILL M | 09-012 | 10-031 | 10-064 | 10-066 |  |  |  |  |  |  |  |  |  |  |  |
| 132121001 |  | RF & Digital Bd Vendor Fab (FIELD Control) |  | 156d | 2010-01-05 | 2010-08-16 | 9-100M FS+60d, 132121000 | 74d | 0d | PROCUREMENT<$50K 60; PROCUREMENT>$50K 69 | 417,538.41 | HOVATER C | 1 | 1 | 08-009 | BILL M |  | 10-031 | 10-064 | 10-066 |  |  |  |  |  |  |  |  |  |  |  |
| 132121005 |  | First Article (RF and Digital) Inspection and Test (IPL 521215020M) |  | 40d | 2010-02-01 | 2010-03-29 | 132121001 FS-138d, 1212125025M | 74d | 0d | ELEC DES [80 h]; ELEC TECH [80 h]; COMP SCIENT [320 h]; OFFICE [40 h]; SUPPLIES & MATERIALS; ELEC ENG [400 h] | 61,211.48 | HOVATER C | 1 | 1 | 08-009 | BILL M |  | 10-031 | 10-064 | 10-066 | IPL |  |  |  |  |  |  |  |  |  |  |
| 132121020M |  | Comp First Article Board Testing (FIELD CONTROL) | milestone | 0d | 2010-03-29 | 2010-03-29 | 132121005 | 74d | 0d |  |  | HOVATER C | 1 | 1 | 08-009 | BILL M |  | 10-031 | 10-064 | 10-066 |  | 6 |  |  |  |  |  |  |  |  |  |
| 132121010 |  | RF Boards Inspection and Testing |  | 98d | 2010-04-12 | 2010-08-27 | 132121005 FS+9d | 74d | 0d | ELEC DES [160 h]; ELEC TECH [400 h]; COMP SCIENT [80 h]; OFFICE [80 h]; SUPPLIES & MATERIALS; ELEC ENG [600 h] | 76,676.53 | HOVATER C | 1 | 1 | 08-009 | BILL M |  | 10-031 | 10-064 | 10-066 |  |  |  |  |  |  |  |  |  |  |  |
| 132121025 |  | Digital Boards Inspection and Testing |  | 98d | 2010-04-12 | 2010-08-27 | 132121005, 132121020M FS+9d | 74d | 0d | ELEC TECH [240 h]; COMP SCIENT [240 h]; ELEC ENG [400 h]; ELEC DES [80 h] | 55,040 | HOVATER C | 1 | 1 | 08-009 | BILL M |  | 10-031 | 10-064 | 10-066 |  |  |  |  |  |  |  |  |  |  |  |
| 132121030M |  | 1/2 Production Boards Tested (FIELD CONTROL) | milestone | 0d | 2010-06-29 | 2010-06-29 | 132121005, 132121025 FS-43d | 126d | 52d |  |  | HOVATER C | 1 | 1 | 08-009 | BILL M |  | 10-031 | 10-064 | 10-066 |  | 6 |  |  |  |  |  |  |  |  |  |
| 132121040 |  | FC Chassis Procure and Fabricate Labor FY10 |  | 66d | 2010-06-29 | 2010-09-30 | 132121010 FS-46d, 9-110M FS-66d | 268d | 0d | OFFICE [18.21 h]; COMP SCIENT [36.41 h]; ELEC ENG [36.41 h]; ELEC TECH [728.28 h]; ELEC DES [72.83 h] | 38,786.95 | HOVATER C | 1 | 1 | 08-009 | BILL M | 09-012 | 10-031 | 10-064 | 10-066 |  |  | 08-016 | 10-028 | 11-001 | 12-028F |  |  |  |  |  |
| 132121040b |  | FC Chassis Procure and Fabricate Procurement |  | 145d | 2010-06-29 | 2011-02-01 | 132121010 FS-46d, 9-110M FS-66d | 268d | 194d | PROCUREMENT<$50K 60 NO ESCALATION FY11 | 103,285.82 | HOVATER C | 1 | 1 | 08-009 | BILL M | 09-012 | 10-031 | 10-064 | 10-066 |  |  | 08-016 | 10-028 | 11-001 | 12-028F |  |  |  |  |  |
| 132121045 |  | First FC Chassis Tested (FIELD Control) Labor FY10 |  | 46d | 2010-07-28 | 2010-09-30 | 132121035M FS-32d, 132121010 FS-23d | 74d | 0d | ELEC TECH [86.59 h]; COMP SCIENT [173.18 h]; OFFICE [21.65 h]; ELEC ENG [216.47 h]; ELEC DES [86.59 h] | 33,294.25 | HOVATER C | 1 | 1 | 08-009 | BILL M | 09-012 | 10-031 | 10-064 | 10-066 |  |  | 08-016 |  | 11-001 |  |  |  |  |  |  |
| 132121045b |  | First FC Chassis Tested (FIELD Control) Procurement |  | 85d | 2010-07-28 | 2010-11-24 | 132121035M FS-32d, 132121010 FS-23d | 74d | 1d | PROCUREMENT<$50K 60 NO ESCALATION FY11 | 10,987.86 | HOVATER C | 1 | 1 | 08-009 | BILL M | 09-012 | 10-031 | 10-064 | 10-066 |  |  | 08-016 |  | 11-001 |  |  |  |  |  |  |
| 132121035M |  | Comp Production Board Testing (FIELD CONTROL) | milestone | 0d | 2010-09-10 | 2010-09-10 | 132121025 FS+9d, 132121030M | 74d | 0d |  |  | HOVATER C | 1 | 1 | 08-009 | BILL M |  | 10-031 | 10-064 | 10-066 |  | 6 |  |  |  |  |  |  |  |  |  |
| 132121040a |  | FC Chassis Procure and Fabricate Labor FY11 |  | 79d | 2010-10-01 | 2011-02-01 | 132121040 | 268d | 194d | ELEC DES [87.17 h]; OFFICE [21.79 h]; COMP SCIENT [43.59 h]; ELEC ENG [43.59 h]; ELEC TECH [871.72 h] | 47,905.93 | HOVATER C | 1 | 1 | 08-009 | BILL M | 09-012 | 10-031 | 10-064 | 10-066 |  |  | 08-016 | 10-028 | 11-001 | 12-028F |  |  |  |  |  |
| 132121045a |  | First FC Chassis Tested (FIELD Control) Labor FY11 |  | 39d | 2010-10-01 | 2010-11-24 | 132121045 | 74d | 1d | ELEC DES [73.41 h]; ELEC TECH [73.41 h]; COMP SCIENT [146.82 h]; OFFICE [18.35 h]; ELEC ENG [183.53 h] | 29,126.97 | HOVATER C | 1 | 1 | 08-009 | BILL M | 09-012 | 10-031 | 10-064 | 10-066 |  |  | 08-016 |  | 11-001 |  |  |  |  |  |  |
| 132121055 |  | FC Chassis Bench Testing (FIELD Control) Labor FY11 |  | 175d | 2011-01-25 | 2011-09-30 | 3A-02M FS-120d, 132121040b FS-200d, 132125020, 32-03M, 132121040a FS-200d | 74d | 0d | ELEC ENG [242.21 h]; COMP SCIENT [48.44 h]; ELEC DES [193.77 h]; ELEC TECH [484.43 h]; OFFICE [48.44 h] | 51,187.06 | HOVATER C | 1 | 1 | 08-009 | BILL M | 09-012 | 10-031 | 10-064 | 10-066 |  |  | 08-016 | 10-028 |  | 12-028F | 12-001 |  |  |  |  |
| 132121055b |  | FC Chassis Bench Testing (FIELD Control) Procurement |  | 289d | 2011-01-25 | 2012-03-22 | 3A-02M FS-120d, 32-03M, 132121040a FS-200d, 132121040b FS-200d, 132125020 | 74d | 0d | PROCUREMENT<$50K 60 NO ESCALATION FY12 | 11,338.37 | HOVATER C | 1 | 1 | 08-009 | BILL M | 09-012 | 10-031 | 10-064 | 10-066 |  |  | 08-016 | 10-028 |  | 12-028F | 12-001 |  |  |  |  |
| 132121061M |  | First Zone Installed/Tested (FIELD CONTROL) | milestone | 0d | 2011-05-02 | 2011-05-02 | 132121060b FS-226d, 132121060a FS-226d | 74d | 0d |  |  | HOVATER C | 1 | 1 | 08-009 | BILL M |  | 10-031 | 10-064 | 10-066 |  | 6 |  | 10-028 |  | 12-028 |  |  |  |  |  |
| 132121062M |  | Second Zone Installed/Tested (FIELD CONTROL) | milestone | 0d | 2011-05-27 | 2011-05-27 | 132121061M FS+20d | 74d | 0d |  |  | HOVATER C | 1 | 1 | 08-009 | BILL M |  | 10-031 | 10-064 | 10-066 |  | 6 |  | 10-028 |  | 12-028 |  |  |  |  |  |
| 132121060 |  | Zone Test & Check (FIELD Control) Labor FY11 Frozen Per CR12-028 |  | 81d | 2011-06-08 | 2011-09-30 | 132121045b, 132121055a FS-195d, 132121055b FS-195d, 132121045a | 95d | 0d | ELEC ENG [133.88 h]; SUPPLIES & MATERIALS; ELEC TECH [147.27 h]; COMP SCIENT [133.88 h]; SCIENTIST [40.17 h]; ELEC DES [133.88 h] | 34,988.3 | HOVATER C | 1 | 1 | 08-009 | BILL M | 09-012 | 10-031 | 10-064 | 10-066 | IPL |  | 08-016 | 10-028 |  | 12-028F | 12-001 |  |  |  |  |
| 132121060b |  | Zone Test & Check (FIELD Control) Procurement Frozen Per CR12-028 |  | 200d | 2011-06-08 | 2012-03-29 | 132121055b FS-195d, 132121045a, 132121055a FS-195d, 132121045b | 74d | 0d | PROCUREMENT<$50K 60 NO ESCALATION FY12 | 5,102.27 | HOVATER C | 1 | 1 | 08-009 | BILL M | 09-012 | 10-031 | 10-064 | 10-066 | IPL |  | 08-016 | 10-028 |  | 12-028 | 12-001 |  |  |  |  |
| 132121063M |  | Third Zone Installed/Tested (FIELD CONTROL) | milestone | 0d | 2011-06-27 | 2011-06-27 | 132121062M FS+20d | 217d | 0d |  |  | HOVATER C | 1 | 1 | 08-009 | BILL M |  | 10-031 | 10-064 | 10-066 |  | 6 |  | 10-028 |  | 12-028 |  | 12-018F |  |  |  |
| 132121064M |  | Fourth Zone Installed/Tested (FIELD CONTROL) | milestone | 0d | 2011-07-26 | 2011-07-26 | 132121063M FS+20d | 217d | 63d |  |  | HOVATER C | 1 | 1 | 08-009 | BILL M |  | 10-031 | 10-064 | 10-066 |  | 6 |  | 10-028 |  | 12-028 |  | 12-018F |  |  |  |
| 132121055a |  | FC Chassis Bench Testing (FIELD Control) Labor FY12 |  | 114d | 2011-10-03 | 2012-03-22 | 132121055 | 74d | 0d | ELEC ENG [157.79 h]; COMP SCIENT [31.56 h]; ELEC DES [126.23 h]; ELEC TECH [315.57 h]; OFFICE [31.56 h] | 34,407.65 | HOVATER C | 1 | 1 | 08-009 | BILL M | 09-012 | 10-031 | 10-064 | 10-066 |  |  | 08-016 | 10-028 |  | 12-028F | 12-001 |  |  |  |  |
| 132121060a |  | Zone Test & Check (FIELD Control) Labor FY12 Frozen Per CR12-028 |  | 98d | 2011-10-03 | 2012-02-29 | 132121060 | 95d | 21d | ELEC TECH [178.18 h]; COMP SCIENT [161.99 h]; SCIENTIST [48.59 h]; ELEC DES [161.99 h]; ELEC ENG [161.99 h]; SUPPLIES & MATERIALS | 43,682.25 | HOVATER C | 1 | 1 | 08-009 | BILL M | 09-012 | 10-031 | 10-064 | 10-066 | IPL |  | 08-016 | 10-028 |  | 12-028 | 12-001 |  |  |  |  |
| 132121060f |  | Reverse Entry Per CR12-028 |  | 15d | 2012-03-05 | 2012-03-23 | 9-120M FS+100d | 132d |  | ELEC ENG [-114 h]; SUPPLIES & MATERIALS; ELEC TECH [-125 h]; COMP SCIENT [-114 h]; SCIENTIST [-33 h]; ELEC DES [-114 h] | -30,632.04 | HOVATER C | 1 | 1 | 08-009 | BILL M | 09-012 | 10-031 | 10-064 | 10-066 | IPL |  | 08-016 | 10-028 |  | 12-028 | 12-001 |  |  |  |  |
| 132121050M |  | Comp FC Bench Testing (FIELD CONTROL) | milestone | 0d | 2012-04-02 | 2012-04-02 | 132121055a FS+7d, 132121055b FS+7d | 344d | 217d |  |  | HOVATER C | 1 | 1 | 08-009 | BILL M |  |  | 10-064 | 10-066 |  | 6 |  | 10-028 |  | 12-028F |  |  | 13-009F |  |  |
| 132121060c |  | Zone Test & Check (FIELD Control) Labor Revised Per CR12-028 |  | 91d | 2012-10-01 | 2013-02-15 | 9-130M | 67d | 0d | ELEC TECH [241.27 h]; COMP SCIENT [219.33 h]; SCIENTIST [65.8 h]; ELEC DES [219.33 h]; ELEC ENG [219.33 h]; SUPPLIES & MATERIALS | 61,010.3 | HOVATER C | 1 | 1 | 08-009 | BILL M | 09-012 | 10-031 | 10-064 | 10-066 | IPL |  | 08-016 | 10-028 |  | 12-028 | 12-001 |  | 13-009F |  |  |
| 132121060d |  | Zone Test & Check (FIELD Control) Procurement Revised Per CR12-028 |  | 99d | 2012-10-01 | 2013-02-28 | 9-130M | 129d | 2d | PROCUREMENT<$50K 60 | 6,435.03 | HOVATER C | 1 | 1 | 08-009 | BILL M | 09-012 | 10-031 | 10-064 | 10-066 | IPL |  | 08-016 | 10-028 |  | 12-028 | 12-001 |  | 13-009F |  |  |
| 132121065M |  | Fifth Zone Installed/Tested (FIELD CONTROL) | milestone | 0d | 2012-10-30 | 2012-10-30 | 132121060c FS-70d, 132121064M FS+20d, 132123020M | 67d | 0d |  |  | HOVATER C | 1 | 1 | 08-009 | BILL M |  | 10-031 | 10-064 | 10-066 |  | 6 |  | 10-028 |  | 12-028 |  | 12-018F | 13-009F |  |  |
| 132121066M |  | Sixth Zone Installed/Tested (FIELD CONTROL) | milestone | 0d | 2012-11-30 | 2012-11-30 | 132121065M FS+22d | 67d | 0d |  |  | HOVATER C | 1 | 1 | 08-009 | BILL M |  | 10-031 | 10-064 | 10-066 |  | 6 |  | 10-028 |  | 12-028 |  | 12-018F | 13-009F |  |  |
| 132121067M |  | Seventh Zone Installed/Tested (FIELD CONTROL) | milestone | 0d | 2012-12-14 | 2012-12-14 | 132121066M FS+10d | 67d | 0d |  |  | HOVATER C | 1 | 1 | 08-009 | BILL M |  | 10-031 | 10-064 | 10-066 |  | 6 |  | 10-028 |  | 12-028 |  | 12-018F | 13-009F |  |  |
| 132121068M |  | Eighth Zone Installed/Tested (FIELD CONTROL) | milestone | 0d | 2013-01-15 | 2013-01-15 | 132121067M FS+16d | 101d | 0d |  |  | HOVATER C | 1 | 1 | 08-009 | BILL M |  |  | 10-064 | 10-066 |  | 6 |  | 10-028 |  | 12-028 |  | 12-018F | 13-009F |  |  |
| 132121069M |  | Ninth Zone Installed/Tested (FIELD CONTROL) | milestone | 0d | 2013-02-01 | 2013-02-01 | 132121068M FS+12d | 113d | 10d |  |  | HOVATER C | 1 | 1 | 08-009 | BILL M |  |  | 10-064 | 10-066 |  | 6 |  | 10-028 |  | 12-028 |  |  | 13-009F |  |  |
| 132121070M |  | Tenth Zone Installed/Tested (FIELD CONTROL) | milestone | 0d | 2013-02-15 | 2013-02-15 | 132121050M, 132121060a, 132121069M, 132121060d FS-10d, 132123025M, 132121060c, 132121060b | 127d | 0d |  |  | HOVATER C | 1 | 1 | 08-009 | BILL M |  |  | 10-064 | 10-066 |  | 6 |  | 10-028 |  | 12-028 |  |  | 13-009F |  |  |
| 132121075 |  | Re-Baseline Actuals Adjustment |  | 1d | 2013-08-30 | 2013-08-30 | 9-130M FS+227d | 20d |  | PROCUREMENT>$50K 69 NO ESCALATION | -271,295.32 | HOVATER C | 1 | 1 |  | BILL M |  |  |  |  |  |  |  |  |  |  |  |  |  | 13-014 | ADJ |

Notes:
- 132121005: Explanation: IPL To 6 GeV BIA / 521215020M
- 132121060: Explanation: IPL from 6 GeV / 53216025M
- 132121060b: Explanation: IPL from 6 GeV / 53216025M
- 132121060a: Explanation: IPL from 6 GeV / 53216025M
- 132121060f: Explanation: IPL from 6 GeV / 53216025M
- 132121060c: Explanation: IPL from 6 GeV / 53216025M
- 132121060d: Explanation: IPL from 6 GeV / 53216025M

| ID | WBS | Activity | Type | Duration | Start | Finish | Predecessors | Total float | Free float | Resources | Cost | RESP - Responsibility | STRT%COMP for CM EVM | FNSH%COMP for CM EVM | CR 08-009 | CAM RESPONSIBLE | CR 10-028 | CR 10-031 | CR 10-064 | CR 10-066 | CR 11-001 | CR 08-016 | CR 09-012 | CR 12-001 | CR 12-018 | CR 12-028 | Milestone Level | CR 13-014 | ReBaseline Actuals Adjustment |
| --- | --- | --- | --- | --- | --- | --- | --- | --- | --- | --- | --- | --- | --- | --- | --- | --- | --- | --- | --- | --- | --- | --- | --- | --- | --- | --- | --- | --- | --- |
|  | 2 | **1.3.2.1.2.2 RESONANCE CONTROL & INTERLOCKS (Interlocks,Tuner Controls)** |  |  | 2010-06-02 | 2013-08-30 |  |  |  |  |  |  |  |  |  |  |  |  |  |  |  |  |  |  |  |  |  |  |  |
| 132122015 |  | Fab & Test Heater & Interlock (RESON CTRL) Labor FY10 |  | 85d | 2010-06-02 | 2010-09-30 | 9-100M FS+163d | 124d | 0d | ELEC DES [148.63 h]; ELEC TECH [427.32 h]; ELEC ENG [130.05 h] | 33,381.83 | HOVATER C | 1 | 1 | 08-009 | BILL M | 10-028 | 10-031 | 10-064 | 10-066 | 11-001 |  |  |  |  |  |  |  |  |
| 132122015b |  | Fab & Test Heater & Interlock (RESON CTRL) Procurement |  | 183d | 2010-06-02 | 2011-03-01 | 9-100M FS+163d | 124d | 0d | PROCUREMENT<$50K 60 NO ESCALATION FY11 | 21,975.7 | HOVATER C | 1 | 1 | 08-009 | BILL M | 10-028 | 10-031 | 10-064 | 10-066 | 11-001 |  |  |  |  |  |  |  |  |
| 132122010 |  | Fab & Test PZT Chassis (RESON CTRL) Phase 1 |  | 1d | 2010-07-01 | 2010-07-01 | 9-100M FS+184d | 154d | 0d | PROCUREMENT<$50K 60; ELEC DES [96 h]; ELEC TECH [368 h]; COMP SCIENT [32 h]; ELEC ENG [96 h] | 36,931.88 | HOVATER C | 1 | 1 | 08-009 | BILL M | 10-028 | 10-031 | 10-064 | 10-066 |  |  |  |  |  |  |  |  |  |
| 132122010a |  | Fab & Test PZT Chassis (RESON CTRL) Phase 2 Labor FY10 |  | 63d | 2010-07-02 | 2010-09-30 | 132122010 | 154d | 0d | ELEC ENG [69.25 h]; ELEC DES [69.25 h]; ELEC TECH [265.47 h]; COMP SCIENT [23.08 h] | 20,300.34 | HOVATER C | 1 | 1 | 08-009 | BILL M | 10-028 | 10-031 | 10-064 | 10-066 | 11-001 |  |  |  |  |  |  |  |  |
| 132122010c |  | Fab & Test PZT Chassis (RESON CTRL) Phase 2 Procurement |  | 131d | 2010-07-02 | 2011-01-14 | 132122010 | 154d | 135d | PROCUREMENT<$50K 60 NO ESCALATION FY11 | 43 | HOVATER C | 1 | 1 | 08-009 | BILL M | 10-028 | 10-031 | 10-064 | 10-066 | 11-001 |  |  |  |  |  |  |  |  |
| 132122000 |  | Bid & Award Matrl & Parts (RESON CTRL) FY10 |  | 19d | 2010-09-03 | 2010-09-30 | 9-110M FS-19d, 1212122170, 1212122110M | 555d | 0d | TRAVEL; ELEC DES [76 h]; OFFICE [25.33 h]; ELEC ENG [38 h] | 7,498.7 | HOVATER C | 1 | 1 | 08-009 | BILL M | 10-028 | 10-031 | 10-064 | 10-066 | 11-001 | 08-016 | 09-012 |  |  |  |  |  |  |
| 132122000a |  | Bid & Award Matrl & Parts (RESON CTRL) FY11 |  | 41d | 2010-10-01 | 2010-11-30 | 132122000 | 555d | 19d | ELEC DES [164 h]; OFFICE [54.67 h]; ELEC ENG [82 h]; TRAVEL | 16,697.26 | HOVATER C | 1 | 1 | 08-009 | BILL M | 10-028 | 10-031 | 10-064 | 10-066 | 11-001 | 08-016 | 09-012 |  |  |  |  |  |  |
| 132122010b |  | Fab & Test PZT Chassis (RESON CTRL) Phase 2 Labor FY11 |  | 68d | 2010-10-01 | 2011-01-14 | 132122010a | 154d | 135d | ELEC DES [74.75 h]; ELEC TECH [286.53 h]; COMP SCIENT [24.92 h]; ELEC ENG [74.75 h] | 22,609.97 | HOVATER C | 1 | 1 | 08-009 | BILL M | 10-028 | 10-031 | 10-064 | 10-066 | 11-001 |  |  |  |  |  |  |  |  |
| 132122015a |  | Fab & Test Heater & Interlock (RESON CTRL) Labor FY11 |  | 98d | 2010-10-01 | 2011-03-01 | 132122015 | 124d | 0d | ELEC DES [171.37 h]; ELEC TECH [492.68 h]; ELEC ENG [149.95 h] | 39,714.06 | HOVATER C | 1 | 1 | 08-009 | BILL M | 10-028 | 10-031 | 10-064 | 10-066 | 11-001 |  |  |  |  |  |  |  |  |
| 132122001 |  | Vend Fab Matrl & Parts (RESON CTRL) |  | 50d | 2011-01-05 | 2011-03-17 | 132122000a, 9-110M FS+60d | 536d | 0d | PROCUREMENT>$50K 69; PROCUREMENT<$50K 60 | 198,421.39 | HOVATER C | 1 | 1 | 08-009 | BILL M | 10-028 | 10-031 | 10-064 | 10-066 |  |  |  |  |  |  |  |  |  |
| 132122020 |  | Zone Test and Check (Reson Ctrl) Labor FY11 Frozen Per CR12-028 |  | 140d | 2011-03-16 | 2011-09-30 | 132122015b FS+10d, 132122015a FS+10d | 376d | 0d | ELEC ENG [66.93 h]; ELEC DES [89.24 h]; ELEC TECH [223.11 h]; COMP SCIENT [89.24 h]; SUPPLIES & MATERIALS | 30,853.14 | HOVATER C | 1 | 1 | 08-009 | BILL M | 10-028 | 10-031 | 10-064 | 10-066 |  | 08-016 | 09-012 | 12-001 | 12-018F | 12-028 |  |  |  |
| 132122020b |  | Zone Test and Check (Reson Ctrl) Procurement Frozen Per CR12-028 |  | 251d | 2011-03-16 | 2012-03-19 | 132122015a FS+10d, 132122015b FS+10d | 363d | 0d | PROCUREMENT<$50K 60 NO ESCALATION FY12 | 11,338.37 | HOVATER C | 1 | 1 | 08-009 | BILL M | 10-028 | 10-031 | 10-064 | 10-066 |  | 08-016 | 09-012 | 12-001 | 12-018F | 12-028 |  |  |  |
| 132122005 |  | Fab & Test Stepper Chassis (RESON CTRL) |  | 107d | 2011-03-18 | 2011-08-17 | 132122001, 9-120M FS-170d | 536d | 501d | ELEC TECH [920 h]; COMP SCIENT [80 h]; PROCUREMENT<$50K 60; ELEC ENG [200 h]; ELEC DES [240 h] | 92,536.32 | HOVATER C | 1 | 1 | 08-009 | BILL M | 10-028 | 10-031 | 10-064 | 10-066 |  |  |  |  |  |  |  |  |  |
| 132122021M |  | First Zone Installed/Tested (RESON CTRL) | milestone | 0d | 2011-06-03 | 2011-06-03 | 132122020a FS-195d, 132122020b FS-195d, 132122010 | 363d | 0d |  |  | HOVATER C | 1 | 1 | 08-009 | BILL M | 10-028 | 10-031 | 10-064 | 10-066 |  |  |  |  | 12-018F | 12-028F | 6 |  |  |
| 132122022M |  | Second Zone Installed/Tested (RESON CTRL) | milestone | 0d | 2011-06-30 | 2011-06-30 | 132122021M FS+20d | 363d | 0d |  |  | HOVATER C | 1 | 1 | 08-009 | BILL M | 10-028 | 10-031 | 10-064 | 10-066 |  |  |  |  | 12-018F | 12-028F | 6 |  |  |
| 132122023M |  | Third Zone Installed/Tested (RESON CTRL) | milestone | 0d | 2011-07-29 | 2011-07-29 | 132122022M FS+20d | 363d | 0d |  |  | HOVATER C | 1 | 1 | 08-009 | BILL M | 10-028 | 10-031 | 10-064 | 10-066 |  |  |  |  | 12-018F | 12-028F | 6 |  |  |
| 132122024M |  | Fourth Zone Installed/Tested (RESON CTRL) | milestone | 0d | 2011-08-26 | 2011-08-26 | 132122023M FS+20d | 363d | 272d |  |  | HOVATER C | 1 | 1 | 08-009 | BILL M | 10-028 | 10-031 | 10-064 | 10-066 |  |  |  |  | 12-018F | 12-028F | 6 |  |  |
| 132122020a |  | Zone Test and Check (Reson Ctrl) Labor FY12 Frozen Per CR12-028 |  | 98d | 2011-10-03 | 2012-02-29 | 132122020 | 376d | 13d | ELEC DES [62.47 h]; ELEC TECH [156.17 h]; COMP SCIENT [62.47 h]; SUPPLIES & MATERIALS; ELEC ENG [46.85 h] | 22,285.26 | HOVATER C | 1 | 1 | 08-009 | BILL M | 10-028 | 10-031 | 10-064 | 10-066 |  | 08-016 | 09-012 | 12-001 | 12-018F | 12-028 |  |  |  |
| 132122020f |  | Reverse Entry Per CR12-028 |  | 15d | 2012-03-05 | 2012-03-23 | 9-120M FS+100d | 132d |  | COMP SCIENT [-78 h]; SUPPLIES & MATERIALS; ELEC ENG [-58 h]; ELEC DES [-78 h]; ELEC TECH [-198 h] | -27,896.2 | HOVATER C | 1 | 1 | 08-009 | BILL M | 10-028 | 10-031 | 10-064 | 10-066 |  | 08-016 | 09-012 | 12-001 | 12-018F | 12-028 |  |  |  |
| 132122020c |  | Zone Test and Check (Reson Ctrl) Labor Revised Per CR12-028 |  | 91d | 2012-10-01 | 2013-02-15 | 9-130M | 91d | 0d | ELEC DES [70.76 h]; ELEC TECH [176.89 h]; COMP SCIENT [70.76 h]; SUPPLIES & MATERIALS; ELEC ENG [53.07 h] | 26,047.63 | HOVATER C | 1 | 1 | 08-009 | BILL M | 10-028 | 10-031 | 10-064 | 10-066 |  | 08-016 | 09-012 | 12-001 | 12-018F | 12-028 |  |  |  |
| 132122020d |  | Zone Test and Check (Reson Ctrl) Procurement Revised Per CR12-028 |  | 99d | 2012-10-01 | 2013-02-28 | 9-130M | 133d | 0d | PROCUREMENT<$50K 60 | 6,435.03 | HOVATER C | 1 | 1 | 08-009 | BILL M | 10-028 | 10-031 | 10-064 | 10-066 |  | 08-016 | 09-012 | 12-001 | 12-018F | 12-028 |  |  |  |
| 132122025M |  | Fifth Zone Installed/Tested (RESON CTRL) | milestone | 0d | 2012-10-30 | 2012-10-30 | 132122024M FS+20d, 132122020c FS-70d | 91d | 0d |  |  | HOVATER C | 1 | 1 | 08-009 | BILL M | 10-028 | 10-031 | 10-064 | 10-066 |  |  |  |  | 12-018F | 12-028 | 6 |  |  |
| 132122026M |  | Sixth Zone Installed/Tested (RESON CTRL) | milestone | 0d | 2012-11-30 | 2012-11-30 | 132122025M FS+22d | 142d | 0d |  |  | HOVATER C | 1 | 1 | 08-009 | BILL M | 10-028 | 10-031 | 10-064 | 10-066 |  |  |  |  | 12-018F | 12-028 | 6 |  |  |
| 132122027M |  | Seventh Zone Installed/Tested (RESON CTRL) | milestone | 0d | 2012-12-14 | 2012-12-14 | 132122026M FS+10d | 142d | 0d |  |  | HOVATER C | 1 | 1 | 08-009 | BILL M | 10-028 | 10-031 | 10-064 | 10-066 |  |  |  |  | 12-018F | 12-028 | 6 |  |  |
| 132122028M |  | Eighth Zone Installed/Tested (RESON CTRL) | milestone | 0d | 2013-01-15 | 2013-01-15 | 132122027M FS+16d | 142d | 0d |  |  | HOVATER C | 1 | 1 | 08-009 | BILL M | 10-028 | 10-031 | 10-064 | 10-066 |  |  |  |  | 12-018F | 12-028 | 6 |  |  |
| 132122029M |  | Ninth Zone Installed/Tested (RESON CTRL) | milestone | 0d | 2013-02-01 | 2013-02-01 | 132122028M FS+12d | 142d | 9d |  |  | HOVATER C | 1 | 1 | 08-009 | BILL M | 10-028 | 10-031 | 10-064 | 10-066 |  |  |  |  | 12-018F | 12-028 | 6 |  |  |
| 132122030M |  | Tenth Zone Installed/Tested (RESON CTRL) | milestone | 0d | 2013-02-15 | 2013-02-15 | 132122029M, 132122020d FS-9d | 133d | 33d |  |  | HOVATER C | 1 | 1 | 08-009 | BILL M | 10-028 | 10-031 | 10-064 | 10-066 |  |  |  |  | 12-018F | 12-028 | 6 |  |  |
| 132122035 |  | Re-Baseline Actuals Adjustment |  | 1d | 2013-08-30 | 2013-08-30 | 9-130M FS+227d | 20d |  | PROCUREMENT>$50K 69 NO ESCALATION | -93,721.4 | HOVATER C | 1 | 1 |  | BILL M |  |  |  |  |  |  |  |  |  |  |  | 13-014 | ADJ |

| ID | WBS | Activity | Type | Duration | Start | Finish | Predecessors | Total float | Free float | Resources | Cost | RESP - Responsibility | STRT%COMP for CM EVM | FNSH%COMP for CM EVM | CR 08-009 | CAM RESPONSIBLE | CR 10-028 | CR 10-031 | CR 10-064 | CR 10-066 | CR 12-018 | CR 12-028 | CR 13-009 | CR 11-001 | CR 08-016 | CR 09-012 | CR 12-001 | Milestone Level | CR 13-014 | ReBaseline Actuals Adjustment |
| --- | --- | --- | --- | --- | --- | --- | --- | --- | --- | --- | --- | --- | --- | --- | --- | --- | --- | --- | --- | --- | --- | --- | --- | --- | --- | --- | --- | --- | --- | --- |
|  | 3 | **1.3.2.1.2.3 PACKAGING/INTERFACE (Racks, Crates)** |  |  | 2010-05-20 | 2013-08-30 |  |  |  |  |  |  |  |  |  |  |  |  |  |  |  |  |  |  |  |  |  |  |  |  |
| 132123005 |  | Production Pwr Supply Delivered & Tested |  | 93d | 2010-05-20 | 2010-09-30 | 1212123055M, 9-100M FS+155d | 454d | 0d | ELEC TECH [160 h]; OFFICE [80 h]; PROCUREMENT<$50K 60; ELEC ENG [40 h]; ELEC DES [160 h] | 51,981.56 | HOVATER C | 1 | 1 | 08-009 | BILL M | 10-028 | 10-031 | 10-064 | 10-066 | 12-018F | 12-028F | 13-009F |  |  |  |  |  |  |  |
| 132123010 |  | Fab Chassis & Cable Harnesses Labor FY10 |  | 65d | 2010-06-30 | 2010-09-30 | 132123005 FS-65d | 454d | 0d | SUPPLIES & MATERIALS; ELEC DES [144.44 h]; ELEC TECH [609.88 h]; OFFICE [32.1 h] | 33,962.28 | HOVATER C | 1 | 1 | 08-009 | BILL M | 10-028 | 10-031 | 10-064 | 10-066 | 12-018F | 12-028F | 13-009F | 11-001 |  |  |  |  |  |  |
| 132123010b |  | Fab Chassis & Cable Harnesses Procurement |  | 162d | 2010-06-30 | 2011-02-28 | 132123005 FS-65d | 454d | 35d | PROCUREMENT<$50K 60 NO ESCALATION FY11 | 32,963.56 | HOVATER C | 1 | 1 | 08-009 | BILL M | 10-028 | 10-031 | 10-064 | 10-066 | 12-018F | 12-028F | 13-009F | 11-001 |  |  |  |  |  |  |
| 132123012 |  | Install Rack Supports & Conduit |  | 60d | 2010-07-02 | 2010-09-27 | 9-100M FS+185d | 459d | 40d | MECH TECH [640 h]; SUPPLIES & MATERIALS | 36,713.6 | HOVATER C | 1 | 1 | 08-009 | BILL M | 10-028 | 10-031 |  | 10-066 | 12-018F | 12-028F | 13-009F |  |  |  |  |  |  |  |
| 132123000 |  | Bid & Award Racks & Cabling FY10 |  | 21d | 2010-09-01 | 2010-09-30 | 1212123170, 9-110M FS-21d | 474d | 0d | ELEC DES [84 h]; ELEC TECH [14 h]; OFFICE [56 h]; ELEC ENG [14 h] | 6,994.4 | HOVATER C | 1 | 1 | 08-009 | BILL M | 10-028 | 10-031 | 10-064 | 10-066 | 12-018F | 12-028F | 13-009F | 11-001 | 08-016 | 09-012 |  |  |  |  |
| 132123000a |  | Bid & Award Racks & Cabling Fy11 |  | 39d | 2010-10-01 | 2010-11-24 | 132123000 | 474d | 21d | OFFICE [104 h]; ELEC ENG [26 h]; ELEC DES [156 h]; ELEC TECH [26 h] | 13,403.78 | HOVATER C | 1 | 1 | 08-009 | BILL M | 10-028 | 10-031 | 10-064 | 10-066 | 12-018F | 12-028F | 13-009F | 11-001 | 08-016 | 09-012 |  |  |  |  |
| 132123010a |  | Fab Chassis & Cable Harnesses Labor FY11 |  | 97d | 2010-10-01 | 2011-02-28 | 132123010 | 454d | 35d | ELEC DES [215.56 h]; ELEC TECH [910.12 h]; OFFICE [47.9 h]; SUPPLIES & MATERIALS | 52,296.46 | HOVATER C | 1 | 1 | 08-009 | BILL M | 10-028 | 10-031 | 10-064 | 10-066 | 12-018F | 12-028F | 13-009F | 11-001 |  |  |  |  |  |  |
| 132123015 |  | Install Chassis, Racks & Cabling Labor FY11 |  | 211d | 2010-11-23 | 2011-09-30 | 132123001 FS-117d, 132123012, 132123010a FS-95d, 132123010b FS-95d, 1321122042a | 419d | 0d | ELEC ENG [836.04 h]; SKLLD TRADE [159.25 h]; SUPPLIES & MATERIALS; ELEC DES [318.49 h]; ELEC TECH [1154.53 h]; OFFICE [79.62 h] | 132,990.77 | HOVATER C | 1 | 1 | 08-009 | BILL M | 10-028 | 10-031 | 10-064 | 10-066 | 12-018F | 12-028F | 13-009F |  | 08-016 | 09-012 | 12-001 |  |  |  |
| 132123015b |  | Install Chassis, Racks & Cabling Labor Procurement |  | 212d | 2010-11-23 | 2011-10-03 | 132123012, 1321122042a, 132123010a FS-95d, 132123010b FS-95d, 132123001 FS-117d | 419d | 0d | PROCUREMENT<$50K 60 NO ESCALATION FY12 | 11,701.2 | HOVATER C | 1 | 1 | 08-009 | BILL M | 10-028 | 10-031 | 10-064 | 10-066 | 12-018F | 12-028F | 13-009F |  | 08-016 | 09-012 | 12-001 |  |  |  |
| 132123001 |  | Vend Fab Racks & Cabling |  | 60d | 2011-01-05 | 2011-03-31 | 132123000a, 9-110M FS+60d | 453d | 34d | PROCUREMENT<$50K 60 | 204,090.58 | HOVATER C | 1 | 1 | 08-009 | BILL M | 10-028 | 10-031 | 10-064 | 10-066 | 12-018F | 12-028F | 13-009F |  |  |  |  |  |  |  |
| 132123020M |  | 5 Racks Installed (PACKAGING) | milestone | 0d | 2011-06-03 | 2011-06-03 | 132123015a FS-85d, 132123015b FS-85d | 419d | 352d |  |  | HOVATER C | 1 | 1 | 08-009 | BILL M | 10-028 | 10-031 | 10-064 | 10-066 | 12-018F | 12-028F | 13-009F |  |  |  |  | 6 |  |  |
| 132123015a |  | Install Chassis, Racks & Cabling Labor FY12 |  | 1d | 2011-10-03 | 2011-10-03 | 132123015 | 419d | 0d | OFFICE [0.38 h]; ELEC ENG [3.96 h]; SKLLD TRADE [0.75 h]; SUPPLIES & MATERIALS; ELEC DES [1.51 h]; ELEC TECH [5.47 h] | 650.08 | HOVATER C | 1 | 1 | 08-009 | BILL M | 10-028 | 10-031 | 10-064 | 10-066 | 12-018F | 12-028F | 13-009F |  | 08-016 | 09-012 | 12-001 |  |  |  |
| 132123025M |  | All Racks Installed (PACKAGING) | milestone | 0d | 2011-10-03 | 2011-10-03 | 132123015b, 132123015a | 464d | 337d |  |  | HOVATER C | 1 | 1 | 08-009 | BILL M | 10-028 |  | 10-064 | 10-066 |  | 12-028F | 13-009F |  |  |  |  | 6 |  |  |
| 132123030 |  | Re-Baseline Actuals Adjustment |  | 1d | 2013-08-30 | 2013-08-30 | 9-130M FS+227d | 20d |  | PROCUREMENT>$50K 69 NO ESCALATION | -28,472.92 | HOVATER C | 1 | 1 |  | BILL M |  |  |  |  |  |  |  |  |  |  |  |  | 13-014 | ADJ |
|  | 4 | **1.3.2.1.2.4 CPU & SOFTWARE** |  |  | 2010-05-03 | 2013-08-30 |  |  |  |  |  |  |  |  |  |  |  |  |  |  |  |  |  |  |  |  |  |  |  |  |
| 132124000 |  | Bid & Award PC104 & Test (CPU) |  | 60d | 2010-05-03 | 2010-07-27 | 9-100M FS+142d | 126d | 0d | SUPPLIES & MATERIALS; ELEC DES [80 h]; COMP SCIENT [80 h]; ELEC TECH [80 h] | 14,458.13 | HOVATER C | 1 | 1 | 08-009 | BILL M | 10-028 | 10-031 | 10-064 | 10-066 |  |  |  |  |  | 09-012 |  |  |  |  |
| 132124001 |  | Vend Fab PC104 & Test (CPU) |  | 86d | 2010-06-02 | 2010-10-01 | 9-100M FS+60d, 132124000 FS-39d | 126d | 0d | PROCUREMENT<$50K 60 NO ESCALATION FY11; PROCUREMENT>$50K 69 NO ESCALATION FY11 | 67,575.29 | HOVATER C | 1 | 1 | 08-009 | BILL M | 10-028 | 10-031 | 10-064 | 10-066 |  |  |  |  | 08-016 | 09-012 |  |  |  |  |
| 132124005 |  | EPICS Interface (CPU) |  | 63d | 2010-10-04 | 2011-01-10 | 132124001 | 283d | 157d | PROCUREMENT<$50K 60; ELEC DES [80 h]; COMP SCIENT [80 h]; SUPPLIES & MATERIALS | 13,640.6 | HOVATER C | 1 | 1 | 08-009 | BILL M | 10-028 | 10-031 | 10-064 | 10-066 |  |  |  |  | 08-016 | 09-012 |  |  |  |  |
| 132124010 |  | Test Software (CPU) |  | 75d | 2010-11-01 | 2011-02-25 | 132124005 FS-200d, 132124001 FS+20d | 126d | 107d | ELEC DES [80 h]; COMP SCIENT [80 h] | 9,003.2 | HOVATER C | 1 | 1 | 08-009 | BILL M | 10-028 | 10-031 | 10-064 | 10-066 |  |  |  |  |  |  |  |  |  |  |
| 132124015 |  | Re-Baseline Actuals Adjustment |  | 1d | 2013-08-30 | 2013-08-30 | 9-130M FS+227d | 20d |  | PROCUREMENT>$50K 69 NO ESCALATION | -59,773.37 | HOVATER C | 1 | 1 |  | BILL M |  |  |  |  |  |  |  |  |  |  |  |  | 13-014 | ADJ |
|  | 5 | **1.3.2.1.2.5 TEST STAND** |  |  | 2009-11-04 | 2013-08-30 |  |  |  |  |  |  |  |  |  |  |  |  |  |  |  |  |  |  |  |  |  |  |  |  |
| 132125000 |  | Bid & Award Test Equipment (Test STAND) |  | 60d | 2009-11-04 | 2010-02-08 | 9-100M FS+24d | 74d | 0d | ELEC DES [80 h]; ELEC ENG [80 h] | 9,096.8 | HOVATER C | 1 | 1 | 08-009 | BILL M | 10-028 | 10-031 | 10-064 | 10-066 |  | 12-028F |  |  |  | 09-012 |  |  |  |  |
| 132125001 |  | Vend Fab Test Equipment (Test STAND) |  | 60d | 2010-02-09 | 2010-05-04 | 9-100M FS+60d, 132125000 | 74d | 0d | PROCUREMENT<$50K 60 | 113,394.64 | HOVATER C | 1 | 1 | 08-009 | BILL M | 10-028 | 10-031 | 10-064 | 10-066 |  | 12-028F |  |  |  |  |  |  |  |  |
| 132125010 |  | Automation Software FY10 |  | 67d | 2010-06-28 | 2010-09-30 | 132125005 FS-65d | 74d | 0d | ELEC ENG [49.17 h]; ELEC DES [98.35 h]; COMP SCIENT [245.87 h] | 23,074.73 | HOVATER C | 1 | 1 | 08-009 | BILL M | 10-028 | 10-031 | 10-064 | 10-066 |  | 12-028F |  | 11-001 |  |  |  |  |  |  |
| 132125005 |  | Assemble Test Stand (Test STAND) |  | 62d | 2010-07-01 | 2010-09-28 | 132125001 FS+40d | 74d | 0d | SUPPLIES & MATERIALS; ELEC ENG [80 h]; ELEC DES [160 h]; ELEC TECH [480 h]; PROCUREMENT<$50K 60 | 73,377.14 | HOVATER C | 1 | 1 | 08-009 | BILL M | 10-028 | 10-031 | 10-064 | 10-066 |  | 12-028F |  |  |  |  |  |  |  |  |
| 132125015 |  | Program Cavity Simulator (Test STAND) FY10 |  | 61d | 2010-07-07 | 2010-09-30 | 132125001 FS+43d | 89d | 0d | ELEC ENG [464.76 h]; ELEC DES [232.38 h] | 41,823.76 | HOVATER C | 1 | 1 | 08-009 | BILL M | 10-028 | 10-031 | 10-064 | 10-066 |  | 12-028F |  | 11-001 |  |  |  |  |  |  |
| 132125010a |  | Automation Software FY11 |  | 42d | 2010-10-01 | 2010-12-01 | 132125010 | 74d | 0d | COMP SCIENT [154.13 h]; ELEC ENG [30.83 h]; ELEC DES [61.65 h] | 14,927.06 | HOVATER C | 1 | 1 | 08-009 | BILL M | 10-028 | 10-031 | 10-064 | 10-066 |  | 12-028F |  | 11-001 |  |  |  |  |  |  |
| 132125015a |  | Program Cavity Simulator (Test STAND) FY11 |  | 2d | 2010-10-01 | 2010-10-04 | 132125015 | 89d | 15d | ELEC ENG [15.24 h]; ELEC DES [7.62 h] | 1,415.11 | HOVATER C | 1 | 1 | 08-009 | BILL M | 10-028 | 10-031 | 10-064 | 10-066 |  | 12-028F |  | 11-001 |  |  |  |  |  |  |
| 132125020 |  | Test Automation (Test STAND) |  | 71d | 2010-10-05 | 2011-01-24 | 132125005, 132125015a FS-15d, 132125010a FS-40d | 74d | 0d | ELEC TECH [400 h]; SUPPLIES & MATERIALS; ELEC ENG [160 h]; ELEC DES [160 h]; COMP SCIENT [160 h]; PROCUREMENT<$50K 60 | 62,439.15 | HOVATER C | 1 | 1 | 08-009 | BILL M | 10-028 | 10-031 | 10-064 | 10-066 |  | 12-028F |  |  |  |  |  |  |  |  |
| 132125025 |  | Re-Baseline Actuals Adjustment |  | 1d | 2013-08-30 | 2013-08-30 | 9-130M FS+227d | 20d |  | PROCUREMENT>$50K 69 NO ESCALATION | -116,587.08 | HOVATER C | 1 | 1 |  | BILL M |  |  |  |  |  |  |  |  |  |  |  |  | 13-014 | ADJ |

| ID | WBS | Activity | Type | Duration | Start | Finish | Predecessors | Total float | Free float | Calendar | Resources | Cost | RESP - Responsibility | STRT%COMP for CM EVM | FNSH%COMP for CM EVM | CR 08-009 | CAM RESPONSIBLE | CR 09-012 | CR 10-028 | CR 10-031 | CR 10-064 | CR 10-066 | Milestone Level | CR 12-001 | CR 12-028 | CR 13-014 | ReBaseline Actuals Adjustment | CR 12-018 | Original Activity ID Rebaseline | CR 13-015 | Post Rebaseline |
| --- | --- | --- | --- | --- | --- | --- | --- | --- | --- | --- | --- | --- | --- | --- | --- | --- | --- | --- | --- | --- | --- | --- | --- | --- | --- | --- | --- | --- | --- | --- | --- |
|  | 6 | **1.3.2.1.2.6 MASTER OSCILLATOR** |  |  |  |  |  |  |  |  |  |  |  |  |  |  |  |  |  |  |  |  |  |  |  |  |  |  |  |  |  |
|  | 7 | **1.3.2.1.2.7 HPA CONTROLS** |  |  | 2010-10-01 | 2013-08-30 |  |  |  |  |  |  |  |  |  |  |  |  |  |  |  |  |  |  |  |  |  |  |  |  |  |
| 132127000 |  | Bid & Award HPA Board (HPA CNTLS) |  | 60d | 2010-10-01 | 2011-01-04 | 9-110M, 1212127065M, 1212127170 | 22d | 0d |  | ELEC DES [80 h]; OFFICE [40 h]; ELEC ENG [40 h] | 7,758 | HOVATER C | 1 | 1 | 08-009 | BILL M | 09-012 | 10-028 | 10-031 | 10-064 | 10-066 |  |  |  |  |  |  |  |  |  |
| 132127005 |  | First Article Test (HPA CNTLS) |  | 38d | 2010-12-02 | 2011-02-02 | 9-110M FS+42d | 63d | 41d |  | ELEC ENG [80 h]; ELEC DES [80 h]; ELEC TECH [160 h] | 16,229.6 | HOVATER C | 1 | 1 | 08-009 | BILL M |  | 10-028 | 10-031 | 10-064 | 10-066 |  |  |  |  |  |  |  |  |  |
| 132127001 |  | Vend Fab HPA Board (HPA CNTLS) |  | 61d | 2011-01-05 | 2011-04-01 | 9-110M FS+60d, 132127000 | 22d | 0d |  | PROCUREMENT<$50K 60 | 40,954.17 | HOVATER C | 1 | 1 | 08-009 | BILL M |  | 10-028 | 10-031 | 10-064 | 10-066 |  |  |  |  |  |  |  |  |  |
| 132127020M |  | Final Bench Test (HPA CNTLS) | milestone | 0d | 2011-02-15 | 2011-02-15 | 132127010M FS-40d, 132127015 FS-140d | 22d | 0d |  |  |  | HOVATER C | 1 | 1 | 08-009 | BILL M |  | 10-028 | 10-031 | 10-064 | 10-066 | 6 |  |  |  |  |  |  |  |  |
| 132127025 |  | Installtn (HPA CNTLS) Labor FY11 Frozen per CR 12-028 |  | 160d | 2011-02-15 | 2011-09-30 | 132127020M | 22d | 0d |  | SUPPLIES & MATERIALS; OFFICE [25.91 h]; ELEC TECH [285.02 h]; ELEC DES [103.64 h]; ELEC ENG [51.82 h] | 23,161.73 | HOVATER C | 1 | 1 | 08-009 | BILL M |  | 10-028 | 10-031 | 10-064 | 10-066 |  | 12-001 |  |  |  |  |  |  |  |
| 132127025b |  | Installtn (HPA CNTLS) Procurement Frozen per CR 12-028 |  | 247d | 2011-02-15 | 2012-02-13 | 132127020M | 22d | 3d |  | PROCUREMENT<$50K 60 NO ESCALATION FY12 | 13,526.66 | HOVATER C | 1 | 1 | 08-009 | BILL M |  | 10-028 | 10-031 | 10-064 | 10-066 |  | 12-001 |  |  |  |  |  |  |  |
| 132127010M |  | Final Board Delivered (HPA CNTLS) | milestone | 0d | 2011-04-01 | 2011-04-01 | 132127005, 132127001 | 22d | 0d |  |  |  | HOVATER C | 1 | 1 | 08-009 | BILL M |  | 10-028 | 10-031 | 10-064 | 10-066 | 6 |  |  |  |  |  |  |  |  |
| 132127015 |  | Chassis Fab & Test (HPA CNTLS) |  | 87d | 2011-05-02 | 2011-09-01 | 132127005, 132127010M FS+20d | 22d | 0d |  | PROCUREMENT<$50K 60; SUPPLIES & MATERIALS; ELEC DES [520 h]; ELEC ENG [80 h]; ELEC TECH [800 h]; COMP SCIENT [80 h]; OFFICE [80 h] | 94,675.74 | HOVATER C | 1 | 1 | 08-009 | BILL M |  | 10-028 | 10-031 | 10-064 | 10-066 |  |  |  |  |  |  |  |  |  |
| 132127025a |  | Installtn (HPA CNTLS) Labor FY12 Frozen per CR 12-028 |  | 87d | 2011-10-03 | 2012-02-13 | 132127025 | 22d | 3d |  | ELEC ENG [28.18 h]; SUPPLIES & MATERIALS; OFFICE [14.09 h]; ELEC TECH [154.98 h]; ELEC DES [56.36 h] | 12,995.66 | HOVATER C | 1 | 1 | 08-009 | BILL M |  | 10-028 | 10-031 | 10-064 | 10-066 |  | 12-001 |  |  |  |  |  |  |  |
| 132127040 |  | Reverse Entry per CR12-028 |  | 15d | 2012-03-05 | 2012-03-23 | 9-120M FS+100d | 132d |  |  | SUPPLIES & MATERIALS; OFFICE [-20 h]; ELEC TECH [-220 h]; ELEC DES [-80 h]; ELEC ENG [-40 h]; PROCUREMENT<$50K 60 | -25,184.56 | HOVATER C | 1 | 1 | 08-009 | BILL M |  | 10-028 | 10-031 | 10-064 | 10-066 |  | 12-001 | 12-028 |  |  |  |  |  |  |
| 132127030 |  | Installtn (HPA CNTLS) Labor Revised per CR12-028 |  | 91d | 2012-10-01 | 2013-02-15 | 9-130M | 51d | 0d |  | SUPPLIES & MATERIALS; OFFICE [20 h]; ELEC TECH [220 h]; ELEC DES [80 h]; ELEC ENG [40 h] | 19,009.21 | HOVATER C | 1 | 1 | 08-009 | BILL M |  | 10-028 | 10-031 | 10-064 | 10-066 |  | 12-001 | 12-028 |  |  |  |  |  |  |
| 132127035 |  | Installtn (HPA CNTLS) Procurement Revised per CR12-028 |  | 99d | 2012-10-01 | 2013-02-28 | 9-130M | 51d | 0d |  | PROCUREMENT<$50K 60 | 6,979.08 | HOVATER C | 1 | 1 | 08-009 | BILL M |  | 10-028 | 10-031 | 10-064 | 10-066 |  | 12-001 | 12-028 |  |  |  |  |  |  |
| 132127045 |  | Re-Baseline Actuals Adjustment |  | 1d | 2013-08-30 | 2013-08-30 | 9-130M FS+227d | 20d |  |  | PROCUREMENT>$50K 69 NO ESCALATION | -26,038.81 | HOVATER C | 1 | 1 |  | BILL M |  |  |  |  |  |  |  |  | 13-014 | ADJ |  |  |  |  |
|  | 3 | **1.3.2.1.3 INSTALLATION & SYSTEM COMMISSIONING (Test Equipment, System Integration Labor)** |  |  | 2010-10-01 | 2013-11-06 |  |  |  |  |  |  |  |  |  |  |  |  |  |  |  |  |  |  |  |  |  |  |  |  |  |
| 13213000 |  | BId & Award Test Equipment (Install & SYS COMMIS) |  | 60d | 2010-10-01 | 2011-01-04 | 9-110M, 132121045a FS-40d, 132121045b FS-40d | 73d | 0d |  | SUPPLIES & MATERIALS; ELEC ENG [80 h]; ELEC DES [80 h] | 12,889.96 | HOVATER C | 1 | 1 | 08-009 | BILL M | 09-012 |  | 10-031 | 10-064 | 10-066 |  |  |  |  |  |  |  |  |  |
| 13213001 |  | Vend Fab Test Equipment (Install & SYS COMMIS) |  | 60d | 2011-01-05 | 2011-03-31 | 9-110M FS+60d, 13213000 | 73d | 0d |  | PROCUREMENT<$50K 60 | 81,636.23 | HOVATER C | 1 | 1 | 08-009 | BILL M |  |  | 10-031 | 10-064 | 10-066 |  |  |  |  |  |  |  |  |  |
| 13213005 |  | Fab & Program RF Test Stand (Install & SYS COMMIS) |  | 60d | 2011-03-03 | 2011-05-25 | 13213001 FS-21d, 1212125025M | 73d | 54d |  | ELEC TECH [200 h]; ELEC DES [200 h]; SUPPLIES & MATERIALS; COMP SCIENT [400 h]; ELEC ENG [320 h] | 68,099.35 | HOVATER C | 1 | 1 | 08-009 | BILL M | 09-012 |  | 10-031 | 10-064 | 10-066 |  |  |  |  |  |  |  |  |  |
| 13213010 |  | RF Sys Tests #1 (Install & SYS COMMIS) |  | 10d | 2011-07-29 | 2011-08-11 | 132122010b, 132127020M, 132121061M, 132112081M FS-5d, 132122010c, 13213005 FS-10d, 132122015a, 132122015b, 132124010, 131501000 FS-5d | 19d | 0d |  | COMP SCIENT [16 h]; OFFICE [8 h]; SUPPLIES & MATERIALS; ELEC DES [56 h]; ELEC ENG [16 h]; ELEC TECH [100 h] | 9,594.86 | HOVATER C | 1 | 1 | 08-009 | BILL M |  | 10-028 | 10-031 | 10-064 | 10-066 |  |  |  |  |  |  |  |  |  |
| 13213015 |  | RF Cavity Tests Cryomodule #1 (Install & SYS COMMIS) |  | 18d | 2011-08-12 | 2011-09-07 | 13213010, 131501005 FS-18d | 522d | 487d |  | SUPPLIES & MATERIALS; ELEC ENG [16 h]; ELEC DES [64 h]; ELEC TECH [60 h]; SCIENTIST [16 h]; OFFICE [8 h] | 8,351.96 | HOVATER C | 1 | 1 | 08-009 | BILL M |  |  |  | 10-064 | 10-066 |  |  |  |  |  |  |  |  |  |
| 13213010a |  | RF Sys Tests #2 (Install & SYS COMMIS) |  | 10d | 2011-08-26 | 2011-09-09 | 132121062M, 132112082M FS-5d, 131502000 FS-5d | 12d | 0d |  | ELEC DES [56 h]; ELEC ENG [16 h]; ELEC TECH [100 h]; COMP SCIENT [16 h]; OFFICE [8 h]; SUPPLIES & MATERIALS | 9,594.86 | HOVATER C | 1 | 1 | 08-009 | BILL M |  | 10-028 | 10-031 |  | 10-066 |  |  |  |  |  |  |  |  |  |
| 13213015a |  | RF Cavity Tests Cryomodule #2 (Install & SYS COMMIS) FY11 |  | 15d | 2011-09-12 | 2011-09-30 | 131502005a FS-18d, 13213010a | 502d | 0d |  | SUPPLIES & MATERIALS; ELEC ENG [13.33 h]; ELEC DES [53.33 h]; ELEC TECH [50 h]; SCIENTIST [13.33 h]; OFFICE [6.67 h] | 6,959.44 | HOVATER C | 1 | 1 | 08-009 | BILL M |  |  |  |  | 10-066 |  | 12-001 |  |  |  |  |  |  |  |
| 13213015ab |  | RF Cavity Tests Cryomodule #2 (Install & SYS COMMIS) FY12 |  | 3d | 2011-10-03 | 2011-10-05 | 13213015a | 502d | 467d |  | ELEC DES [10.67 h]; ELEC TECH [10 h]; SCIENTIST [2.67 h]; OFFICE [1.33 h]; SUPPLIES & MATERIALS; ELEC ENG [2.67 h] | 1,436.87 | HOVATER C | 1 | 1 | 08-009 | BILL M |  |  |  |  | 10-066 |  | 12-001 |  |  |  |  |  |  |  |
| 13213010b |  | RF Sys Tests #3 (Install & SYS COMMIS) |  | 10d | 2012-05-29 | 2012-06-12 | 132121063M, 131504000, 132112083M FS-5d | 312d | 0d |  | ELEC ENG [16 h]; ELEC TECH [100 h]; COMP SCIENT [16 h]; OFFICE [8 h]; SUPPLIES & MATERIALS; ELEC DES [56 h] | 9,900.4 | HOVATER C | 1 | 1 | 08-009 | BILL M |  | 10-028 | 10-031 |  | 10-066 |  |  | 12-028 |  |  | 12-018 |  |  |  |
| 13213010c |  | RF Sys Tests #4 (Install & SYS COMMIS) |  | 10d | 2012-06-11 | 2012-06-22 | 131505000, 132121064M, 132112084M FS-5d | 35d | 0d |  | ELEC DES [56 h]; ELEC ENG [16 h]; ELEC TECH [100 h]; COMP SCIENT [16 h]; OFFICE [8 h]; SUPPLIES & MATERIALS | 9,900.4 | HOVATER C | 1 | 1 | 08-009 | BILL M |  | 10-028 | 10-031 |  | 10-066 |  |  | 12-028 |  |  | 12-018 |  |  |  |
| 13213015c |  | RF Cavity Tests Cryomodule #4 (Install & SYS COMMIS) |  | 18d | 2012-06-25 | 2012-07-18 | 131504005 FS-18d, 13213010c | 309d | 274d |  | ELEC DES [64 h]; ELEC TECH [60 h]; SCIENTIST [16 h]; OFFICE [8 h]; SUPPLIES & MATERIALS; ELEC ENG [16 h] | 8,617.94 | HOVATER C | 1 | 1 | 08-009 | BILL M |  |  |  |  | 10-066 |  |  | 12-028 |  |  | 12-018 |  |  |  |
| 13213015d |  | RF Cavity Tests Cryomodule #5 (Install & SYS COMMIS) |  | 18d | 2012-07-04 | 2012-07-27 | 13213010b, 131505005 FS-18d | 302d | 267d |  | ELEC ENG [16 h]; ELEC DES [64 h]; ELEC TECH [60 h]; SCIENTIST [16 h]; OFFICE [8 h]; SUPPLIES & MATERIALS | 8,617.94 | HOVATER C | 1 | 1 | 08-009 | BILL M |  |  |  |  | 10-066 |  |  | 12-028 |  |  | 12-018 |  |  |  |
| 13213020M |  | Comp Cavity Tests (INSTALL & SYS COMMIS) | milestone | 0d | 2013-08-23 | 2013-08-23 | 132113125, 181315025, 181321045, 13213015c, 132122005, 13213015ab, 13213015, 13213015d, 181321055, 181321030, 181321035, 181321050, 181321040 | 35d |  |  |  |  | HOVATER C | 1 | 1 | 08-009 | BILL M |  |  |  |  | 10-066 | 6 |  | 12-028 |  |  | 12-018 |  |  |  |
| 13213025 |  | Re-Baseline Actuals Adjustment |  | 1d | 2013-08-30 | 2013-08-30 | 9-130M FS+227d | 20d |  |  | PROCUREMENT>$50K 69 NO ESCALATION | -13,235.28 | HOVATER C | 1 | 1 |  | BILL M |  |  |  |  |  |  |  |  | 13-014 | ADJ |  |  |  |  |
| 23213020M |  | Comp Cavity Tests (INSTALL & SYS COMMIS) | milestone | 0d | 2013-11-06 | 2013-11-06 | 232113125, 281315025, 281321055, 281315025a, 281321050 | 28d |  | 8/5 M-F w/JLAB Holidays ReBaseline |  |  | HOVATER C | 1 | 1 | 08-009 | BILL M |  |  |  |  | 10-066 | 6 |  | 12-028 |  |  | 12-018 | 23213020M | 13-015 | PR |

| ID | WBS | Activity | Type | Duration | Start | Finish | Predecessors | Total float | Free float | Resources | Cost | RESP - Responsibility | STRT%COMP for CM EVM | FNSH%COMP for CM EVM | CAM RESPONSIBLE | CR 08-059 | CR 10-028 | CR 11-055 | CR 12-029 | CR 12-050 | Milestone Level | Advance Purchase Plan > 500K | CR 08-016 | 12 GEV MAJOR PROCUREMENT CATAGORY | CR 09-012 | CR 10-040 | CR 10-066 | CR 12-028 | CR 12-035 | CR 08-010 | CR 12-001 |
| --- | --- | --- | --- | --- | --- | --- | --- | --- | --- | --- | --- | --- | --- | --- | --- | --- | --- | --- | --- | --- | --- | --- | --- | --- | --- | --- | --- | --- | --- | --- | --- |
|  | 4 | **1.3.2.1.4 SYSTEM OPERATION** |  |  |  |  |  |  |  |  |  |  |  |  |  |  |  |  |  |  |  |  |  |  |  |  |  |  |  |  |  |
|  | 2 | **1.3.2.2 MAGNET POWER** |  |  | 2009-01-02 | 2014-09-30 |  |  |  |  |  |  |  |  |  |  |  |  |  |  |  |  |  |  |  |  |  |  |  |  |  |
|  | 1 | **1.3.2.2.1 BOX SUPPLIES** |  |  | 2009-01-02 | 2014-09-30 |  |  |  |  |  |  |  |  |  |  |  |  |  |  |  |  |  |  |  |  |  |  |  |  |  |
| 13221028 |  | Prcrmnt Prep for Box 600/500kW PS - Arc & Septa (Box SUPPLIES) |  | 60d | 2009-01-02 | 2009-03-30 | 9-090M FS+59d, 121221150 | 971d | 189d | ELEC ENG [160 h]; ELEC DES [80 h] | 13,955.2 | MERZ B | 1 | 1 | BILL M | 08-059 | 10-028 | 11-055 | 12-029F | 12-050F |  |  |  |  |  |  |  |  |  |  |  |
| 13221029M |  | Award Box 600/500 KW PS (BOX SUPPLIES) | milestone | 0d | 2010-01-05 | 2010-01-05 | 13221028, 9-100M FS+60d | 782d | 0d |  |  | MERZ B | 1 | 1 | BILL M |  | 10-028 | 11-055 | 12-029F | 12-050F | 6 |  |  |  |  |  |  |  |  |  |  |
| 13221030 |  | Vend Fab Box 600/500 kW PS - Original Travel Expenses |  | 37d | 2010-01-05 | 2010-02-26 | 13221029M, 9-100M FS+60d | 878d | 752d | TRAVEL | 492.78 | MERZ B | 1 | 1 | BILL M |  | 10-028 | 11-055 | 12-029F | 12-050F |  | APP | 08-016 | 3221 | 09-012 | 10-040 |  |  |  |  |  |
| 13221035 |  | Monitor Contract Vend Progress- 600/500kW Box PS Original Labor |  | 37d | 2010-01-05 | 2010-02-26 | 9-100M FS+60d, 13221029M | 782d | 14d | ELEC ENG [17.94 h] | 1,188.88 | MERZ B | 1 | 1 | BILL M |  | 10-028 | 11-055 | 12-029F | 12-050F |  |  |  |  |  | 10-040 |  |  |  |  |  |
| 13221010N |  | Vend Fab Magnet System Box Power Supplies Peg Point #12 Delivery and Accp of Prod PS (QTY 2) (Frozen Per CR11-055) |  | 365d | 2010-03-18 | 2011-08-31 | 9-100M FS+110d | 1024d | 0d | PROCUREMENT>$50K 69 NO ESCALATION | 339,253.6 | MERZ B | 1 | 1 | BILL M |  | 10-028 | 11-055 | 12-029F | 12-050F |  |  |  |  |  | 10-040 |  |  |  |  |  |
| 13221010P |  | Vend Fab Magnet System Box Power Supplies Peg Point #13 Delivery and Accp of Spare Parts (Frozen Per CR11-055) |  | 365d | 2010-03-18 | 2011-08-31 | 13221010N FS-365d | 1024d | 482d | PROCUREMENT>$50K 69 NO ESCALATION | 92,000 | MERZ B | 1 | 1 | BILL M |  | 10-028 | 11-055 | 12-029F | 12-050F |  |  |  |  |  | 10-040 |  |  |  |  |  |
| 13221005 |  | Vend Fab Magnet System Box Power Supplies Oversight FY10 |  | 137d | 2010-03-19 | 2010-09-30 | 13221004M FS-137d, 13221035 | 768d | 0d | ELEC ENG [156.4 h]; TRAVEL | 16,710.95 | MERZ B | 1 | 1 | BILL M |  | 10-028 | 11-055 | 12-029F | 12-050F |  | APP | 08-016 | 3221 |  | 10-040 |  |  |  |  |  |
| 13221010 |  | Vend Fab Magnet System Box Power Supplies Peg Point #1 Preliminary Design Report |  | 51d | 2010-03-19 | 2010-05-28 | 13221004M FS-137d | 542d | 0d |  |  | MERZ B | 1 | 1 | BILL M |  | 10-028 | 11-055 | 12-029F | 12-050F |  |  |  |  |  | 10-040 |  |  |  |  |  |
| 13221010A |  | Vend Fab Magnet System Box Power Supplies Peg Point #2 Design Review and Approval |  | 73d | 2010-03-19 | 2010-06-30 | 13221010 FS-51d | 542d | 0d | PROCUREMENT>$50K 69 NO ESCALATION; PROCUREMENT<$50K 60 NO ESCALATION | 424,067 | MERZ B | 1 | 1 | BILL M |  | 10-028 | 11-055 | 12-029F | 12-050F |  |  |  |  |  | 10-040 |  |  |  |  |  |
| 13221010B |  | Vend Fab Magnet System Box Power Supplies Peg Point #3 First Article Testing - First Topology (Frozen Per CR11-055) |  | 195d | 2010-03-19 | 2010-12-30 | 13221010A FS-73d | 542d | 0d | PROCUREMENT>$50K 69 NO ESCALATION | 169,626.8 | MERZ B | 1 | 1 | BILL M |  | 10-028 | 11-055 | 12-029F | 12-050F |  |  |  |  |  | 10-040 |  |  |  |  |  |
| 13221010C |  | Vend Fab Magnet System Box Power Supplies Peg Point #4 First Article Testing - All Topologies (Frozen Per CR11-055) |  | 234d | 2010-03-19 | 2011-02-28 | 13221010B FS-195d | 542d | 0d | PROCUREMENT>$50K 69 NO ESCALATION | 169,626.8 | MERZ B | 1 | 1 | BILL M |  | 10-028 | 11-055 | 12-029F | 12-050F |  |  |  |  |  | 10-040 |  |  |  |  |  |
| 13221010D |  | Vend Fab Magnet System Box Power Supplies Peg Point #5 Delivery and Accp of Prod Power Supplies (Frozen Per CR11-055) |  | 257d | 2010-03-19 | 2011-03-31 | 13221010C FS-234d | 542d | 0d | PROCUREMENT>$50K 69 NO ESCALATION | 169,626.8 | MERZ B | 1 | 1 | BILL M |  | 10-028 | 11-055 | 12-029F | 12-050F |  |  |  |  |  | 10-040 |  |  |  |  |  |
| 13221010H |  | Vend Fab Magnet System Box Power Supplies Peg Point #8 Delivery and Accp of Prod Power Supplies (Frozen Per CR11-055) |  | 321d | 2010-03-19 | 2011-06-30 | 13221010D FS-257d | 542d | 0d | PROCUREMENT>$50K 69 NO ESCALATION | 424,067 | MERZ B | 1 | 1 | BILL M |  | 10-028 | 11-055 | 12-029F | 12-050F |  |  |  |  |  | 10-040 |  |  |  |  |  |
| 13221077 |  | Dummy Load Design Re-work / Documentation |  | 42d | 2010-05-04 | 2010-07-01 | 9-100M FS+143d | 772d | 0d | ELEC ENG [80 h] | 5,301.6 | MERZ B | 1 | 1 | BILL M |  | 10-028 | 11-055 | 12-029F | 12-050F |  |  |  |  |  | 10-040 | 10-066 |  |  |  |  |
| 13221095 |  | Engineering Oversight - Develop/Conduct Procedures, Q.A. and Training FY10 |  | 98d | 2010-05-13 | 2010-09-30 | 9-100M FS+150d | 227d | 0d | ELEC TECH [12.56 h]; ELEC ENG [119 h]; ELEC DES [12.56 h] | 9,002.59 | MERZ B | 1 | 1 | BILL M |  | 10-028 |  |  |  |  |  |  |  |  | 10-040 |  |  |  |  |  |
| 13221078 |  | Order Dummy Load Parts |  | 21d | 2010-07-02 | 2010-08-02 | 13221077 | 772d | 0d | ELEC DES [40 h]; ELEC ENG [40 h] | 4,548.4 | MERZ B | 1 | 1 | BILL M |  | 10-028 | 11-055 | 12-029F | 12-050F |  |  |  |  |  |  | 10-066 |  |  |  |  |
| 13221003 |  | Bid/Award Box 1000 kW PS - Arc (Box SUPPLIES) |  | 60d | 2010-07-08 | 2010-09-30 | 9-110M FS-60d | -129d | 0d | ELEC DES [80 h]; ELEC ENG [160 h] | 14,398.4 | MERZ B | 1 | 1 | BILL M |  |  |  |  |  |  |  |  |  |  |  |  |  |  |  |  |
| 13221053 |  | Bid/Award Box Low Power PS - Transport (Box SUPPLIES) |  | 60d | 2010-07-08 | 2010-09-30 | 9-110M FS-60d | -129d | 0d | ELEC DES [80 h]; ELEC ENG [160 h] | 14,398.4 | MERZ B | 1 | 1 | BILL M |  |  |  | 12-029F |  |  |  |  |  |  |  |  | 12-028F |  |  |  |
| 13221080 |  | Dummy Load Procurement |  | 44d | 2010-08-03 | 2010-10-04 | 13221078 | 772d | 0d | PROCUREMENT<$50K 60 NO ESCALATION FY11 | 82,000 | MERZ B | 1 | 1 | BILL M |  | 10-028 | 11-055 | 12-029F | 12-050F |  | APP |  |  |  |  | 10-066 |  |  |  |  |
| 13221004M |  | Award Magnet System Box Power Supplies | milestone | 0d | 2010-10-01 | 2010-10-01 | 13221003, 13221054M | -129d | 0d |  |  | MERZ B | 1 | 1 | BILL M |  |  |  |  |  | 6 |  |  |  |  |  |  |  |  |  |  |
| 13221005A |  | Vend Fab Magnet System Box Power Supplies Oversight FY11 |  | 248d | 2010-10-01 | 2011-09-30 | 13221005 | 768d | 0d | ELEC ENG [282 h]; TRAVEL | 25,831.93 | MERZ B | 1 | 1 | BILL M |  | 10-028 | 11-055 | 12-029F | 12-050F |  | APP |  | 3221 |  | 10-040 |  |  |  |  |  |
| 13221054M |  | Award Box Low Power PS (BOX SUPPLIES) | milestone | 0d | 2010-10-01 | 2010-10-01 | 9-110M, 13221053 | -129d | 0d |  |  | MERZ B | 1 | 1 | BILL M |  |  |  | 12-029F |  | 6 |  |  |  |  |  |  | 12-028F |  |  |  |
| 13221095LOE |  | Engineering Oversight - Develop/Conduct Procedures, Q.A. and Training FY11 |  | 248d | 2010-10-01 | 2011-09-30 | 13221095 | 227d | 0d | ELEC ENG [302.2 h]; ELEC DES [31.79 h]; ELEC TECH [31.79 h] | 23,580.22 | MERZ B | 1 | 1 | BILL M |  | 10-028 |  |  |  |  |  |  |  |  |  |  |  |  |  |  |
| 13221118 |  | Bid Compnts to Refurb 5 PS (Box SUPPLIES) |  | 80d | 2010-10-01 | 2011-02-02 | 9-110M | 459d | 0d | ELEC ENG [80 h]; ELEC DES [40 h] | 7,428.4 | MERZ B | 1 | 1 | BILL M |  | 10-028 |  | 12-029F |  |  |  |  |  |  |  |  | 12-028F |  |  |  |
| 13221085 |  | Dummy Load - Fabricate Sub Assemblies |  | 50d | 2010-10-05 | 2010-12-15 | 13221080 | 772d | 0d | ELEC TECH [400 h] | 17,108 | MERZ B | 1 | 1 | BILL M |  | 10-028 | 11-055 | 12-029F | 12-050F |  |  |  |  |  |  | 10-066 |  |  |  |  |
| 13221098 |  | Procure Extraction YA PS & Shunt Sub assemblies |  | 50d | 2010-12-07 | 2011-02-24 | 9-110M FS+45d | 300d | 0d | ELEC ENG [80 h]; PROCUREMENT<$50K 60; ELEC TECH [120 h] | 33,279.52 | MERZ B | 1 | 1 | BILL M |  | 10-028 |  | 12-029F |  |  | APP |  |  |  |  |  | 12-028F | 12-035F |  |  |
| 13221090 |  | Dummy Load Assemble Unit #1 |  | 45d | 2010-12-16 | 2011-02-28 | 13221085 | 772d | 0d | ELEC TECH [280 h]; ELEC ENG [40 h]; ELEC DES [40 h] | 16,668.8 | MERZ B | 1 | 1 | BILL M |  | 10-028 | 11-055 | 12-029F | 12-050F |  |  |  |  |  |  | 10-066 |  |  |  |  |
| 13221119M |  | Award Components to Refurb 6 PS (BOX SUPPLIES) Frozen Per CR 12-028 | milestone | 0d | 2011-02-03 | 2011-02-03 | 13221118 | 459d | 0d |  |  | MERZ B | 1 | 1 | BILL M |  | 10-028 |  | 12-029F |  | 6 |  |  |  |  |  |  | 12-028F |  |  |  |
| 13221120 |  | Vend Fab Compnts to Refurb 6 PS (Box SUPPLIES) Frozen Per CR 12-028 |  | 80d | 2011-02-03 | 2011-05-26 | 13221119M | 459d | 238d | PROCUREMENT>$50K 69 | 101,694.78 | MERZ B | 1 | 1 | BILL M |  | 10-028 |  | 12-029F |  |  | APP |  |  |  |  |  | 12-028F |  | 08-010 |  |
| 13221125 |  | Monitor Delivery & Receive PS Compnts (Box SUPPLIES) Frozen Per CR 12-028 |  | 80d | 2011-02-03 | 2011-05-26 | 13221119M | 459d | 238d | ELEC TECH [40 h]; ELEC ENG [40 h] | 4,446 | MERZ B | 1 | 1 | BILL M |  | 10-028 |  | 12-029F |  |  |  |  |  |  |  |  | 12-028F |  |  |  |
| 13221099M |  | Award H-D & Lambertson (2) PS (BOX SUPPLIES) | milestone | 0d | 2011-02-25 | 2011-02-25 | 13221098, 9-100M FS+60d | 300d | 0d |  |  | MERZ B | 1 | 1 | BILL M |  | 10-028 |  | 12-029F |  | 6 |  |  |  |  |  |  | 12-028F | 12-035F |  |  |
| 13221100 |  | Assemble YA PS and Shunt subassemblies |  | 100d | 2011-02-25 | 2011-07-18 | 13221099M | 300d | 0d | SUPPLIES & MATERIALS; ELEC DES [160 h]; ELEC TECH [480 h] | 34,030.79 | MERZ B | 1 | 1 | BILL M |  | 10-028 |  | 12-029F |  |  |  |  |  |  |  |  | 12-028F | 12-035F |  |  |
| 13221105 |  | Install and Check-out YA & Shunt hardware |  | 30d | 2011-02-25 | 2011-04-07 | 13221099M | 370d | 70d | ELEC TECH [160 h]; ELEC ENG [80 h] | 12,313.6 | MERZ B | 1 | 1 | BILL M |  | 10-028 |  | 12-029F |  |  |  |  |  |  |  |  | 12-028F | 12-035F |  |  |
| 13221015 |  | Receive & Inpect Magnet System Box Power Supplies (Frozen per CR11-055) |  | 107d | 2011-03-01 | 2011-07-29 | 9-110M FS+97d | 833d | 291d | ELEC TECH [79.63 h] | 3,405.78 | MERZ B | 1 | 1 | BILL M |  | 10-028 | 11-055 | 12-029F | 12-050F |  |  |  |  |  | 10-040 |  |  |  |  |  |
| 13221092 |  | Dummy Load Assemble Unit #2 |  | 45d | 2011-03-01 | 2011-05-02 | 13221090 | 772d | 569d | ELEC TECH [280 h]; ELEC ENG [40 h]; ELEC DES [40 h] | 16,668.8 | MERZ B | 1 | 1 | BILL M |  | 10-028 | 11-055 | 12-029F | 12-050F |  |  |  |  |  |  | 10-066 |  |  |  |  |
| 13221093 |  | Rental for Dummy Load Water Skid FY11 |  | 118d | 2011-04-15 | 2011-09-30 | 4A-01M FS-20d | 1d | 0d | ELEC ENG [32.11 h]; SUPPLIES & MATERIALS | 60,178.64 | MERZ B | 1 | 1 | BILL M |  | 10-028 |  |  |  |  |  |  |  |  |  | 10-066 |  |  |  | 12-001 |
| 13221020 |  | Place/Connect/Check-out Magnet System Box Power Supplies (Frozen per CR11-055) |  | 13d | 2011-07-13 | 2011-07-29 | 9-110M FS+191d | 890d | 687d | ELEC TECH [80.39 h]; COMP SCIENT [16.08 h]; SUPPLIES & MATERIALS; ELEC ENG [40.19 h]; ELEC DES [40.19 h] | 10,101.99 | MERZ B | 1 | 1 | BILL M |  | 10-028 | 11-055 | 12-029F | 12-050F |  |  |  |  |  | 10-040 |  |  |  |  |  |
| 13221115 |  | Test Extraction PS Systems |  | 20d | 2011-07-19 | 2011-08-15 | 13221100, 13221105 | 300d | 280d | COMP SCIENT [40 h]; ELEC ENG [40 h]; ELEC TECH [40 h] | 6,989.6 | MERZ B | 1 | 1 | BILL M |  | 10-028 |  | 12-029F |  |  |  |  |  |  |  |  | 12-028F | 12-035F |  |  |
| 13221010J |  | Reverse Entry Per CR 11-055 |  | 5d | 2011-08-01 | 2011-08-05 | 9-110M FS+204d | 39d |  | COMP SCIENT [-16.08 h]; SUPPLIES & MATERIALS; PROCUREMENT>$50K 69 NO ESCALATION; ELEC TECH [-160.02 h]; ELEC DES [-40.19 h]; ELEC ENG [-40.19 h] | -1,377,708.77 | MERZ B | 1 | 1 | BILL M |  | 10-028 | 11-055 |  |  |  |  |  |  |  | 10-040 |  |  |  |  |  |
| 13221010K |  | Revised Schedule per CR11-055 Vend Fab Magnet Box Power Supplies 1st Article M1 Topology (T&M PS) |  | 65d | 2011-08-01 | 2011-10-31 | 13221010H FS+20d | 542d | 0d | PROCUREMENT>$50K 69 NO ESCALATION | 169,626.8 | MERZ B | 1 | 1 | BILL M |  | 10-028 | 11-055 | 12-029F | 12-050F |  |  |  |  |  | 10-040 |  |  |  |  |  |
| 13221010L |  | Revised Schedule per CR11-055 Vend Fab Magnet Box Power Supplies Delivery of LAM1C |  | 122d | 2011-08-01 | 2012-01-31 | 13221010K FS-65d | 542d | 0d | PROCUREMENT>$50K 69 NO ESCALATION | 73,300 | MERZ B | 1 | 1 | BILL M |  | 10-028 | 11-055 | 12-029F | 12-050F |  |  |  |  |  | 10-040 |  |  |  |  |  |
| 13221010Na |  | Revised Schedule per CR11-055 Vend Fab Magnet Box Power Supplies Delivery of LAM3C |  | 142d | 2011-08-01 | 2012-02-29 | 13221010L FS-122d | 542d | 0d | PROCUREMENT>$50K 69 NO ESCALATION | 73,300 | MERZ B | 1 | 1 | BILL M |  | 10-028 | 11-055 | 12-029F | 12-050F |  |  |  |  |  | 10-040 |  |  |  |  |  |
| 13221010Pa |  | Revised Schedule per CR11-055 Vend Fab Magnet Box Power Supplies Delivery of XSEP10 |  | 164d | 2011-08-01 | 2012-03-30 | 13221010Na FS-142d | 542d | 0d | PROCUREMENT>$50K 69 NO ESCALATION | 73,300 | MERZ B | 1 | 1 | BILL M |  | 10-028 | 11-055 | 12-029F | 12-050F |  |  |  |  |  | 10-040 |  |  |  |  |  |
| 13221010Q |  | Revised Schedule per CR11-055 Vend Fab Magnet Box Power Supplies Delivery of XSEP8 |  | 164d | 2011-08-01 | 2012-03-30 | 13221010P FS-505d, 13221010Pa FS-164d | 542d | 0d | PROCUREMENT>$50K 69 NO ESCALATION | 73,300 | MERZ B | 1 | 1 | BILL M |  | 10-028 | 11-055 | 12-029F | 12-050F |  |  |  |  |  | 10-040 |  |  |  |  |  |
| 13221010R |  | Revised Schedule per CR11-055 Vend Fab Magnet Box Power Supplies Delivery of RSEP9A |  | 164d | 2011-08-01 | 2012-03-30 | 13221010Q FS-164d | 542d | 0d | PROCUREMENT>$50K 69 NO ESCALATION | 73,300 | MERZ B | 1 | 1 | BILL M |  | 10-028 | 11-055 | 12-029 | 12-050F |  |  |  |  |  | 10-040 |  |  |  |  |  |
| 13221010S |  | Revised Schedule per CR11-055 Vend Fab Magnet Box Power Supplies Delivery of RSEP8A |  | 164d | 2011-08-01 | 2012-03-30 | 13221010R FS-164d | 542d | 0d | PROCUREMENT>$50K 69 NO ESCALATION | 73,300 | MERZ B | 1 | 1 | BILL M |  | 10-028 | 11-055 | 12-029 | 12-050F |  |  |  |  |  | 10-040 |  |  |  |  |  |
| 13221010T |  | Revised Schedule per CR11-055 Vend Fab Magnet Box Power Supplies Delivery of ARC2 |  | 164d | 2011-08-01 | 2012-03-30 | 13221010S FS-164d | 542d | 0d | PROCUREMENT>$50K 69 NO ESCALATION | 73,300 | MERZ B | 1 | 1 | BILL M |  | 10-028 | 11-055 | 12-029 | 12-050F |  |  |  |  |  | 10-040 |  |  |  |  |  |
| 13221010U |  | Revised Schedule per CR11-055 Vend Fab Magnet Box Power Supplies Delivery of ARC4 |  | 164d | 2011-08-01 | 2012-03-30 | 13221010T FS-164d | 542d | 0d | PROCUREMENT>$50K 69 NO ESCALATION | 73,300 | MERZ B | 1 | 1 | BILL M |  | 10-028 | 11-055 | 12-029 | 12-050F |  |  |  |  |  | 10-040 |  |  |  |  |  |
| 13221010V |  | Revised Schedule per CR11-055 Vend Fab Magnet Box Power Supplies Delivery of ARC5 |  | 164d | 2011-08-01 | 2012-03-30 | 13221010U FS-164d | 542d | 0d | PROCUREMENT>$50K 69 NO ESCALATION | 73,300 | MERZ B | 1 | 1 | BILL M |  | 10-028 | 11-055 | 12-029 | 12-050F |  |  |  |  |  | 10-040 |  |  |  |  |  |
| 13221010W |  | Revised Schedule per CR11-055 Vend Fab Magnet Box Power Supplies Delivery of ARC7 |  | 164d | 2011-08-01 | 2012-03-30 | 13221010V FS-164d | 542d | 0d | PROCUREMENT>$50K 69 NO ESCALATION | 73,300 | MERZ B | 1 | 1 | BILL M |  | 10-028 | 11-055 | 12-029 | 12-050F |  |  |  |  |  | 10-040 |  |  |  |  |  |
| 13221010X |  | Revised Schedule per CR11-055 Vend Fab Magnet Box Power Supplies Delivery of ARC3 |  | 164d | 2011-08-01 | 2012-03-30 | 13221010W FS-164d | 542d | 0d | PROCUREMENT>$50K 69 NO ESCALATION | 73,300 | MERZ B | 1 | 1 | BILL M |  | 10-028 | 11-055 | 12-029 | 12-050F |  |  |  |  |  | 10-040 |  |  |  |  |  |
| 13221010Y |  | Revised Schedule per CR11-055 Vend Fab Magnet Box Power Supplies Delivery of ARC6 |  | 164d | 2011-08-01 | 2012-03-30 | 13221010X FS-164d | 542d | 0d | PROCUREMENT>$50K 69 NO ESCALATION | 73,300 | MERZ B | 1 | 1 | BILL M |  | 10-028 | 11-055 | 12-029 | 12-050F |  |  |  |  |  | 10-040 |  |  |  |  |  |
| 13221010Z |  | Revised Schedule per CR11-055 Vend Fab Magnet Box Power Supplies Delivery of ARC10 |  | 164d | 2011-08-01 | 2012-03-30 | 13221010Y FS-164d | 542d | 0d | PROCUREMENT>$50K 69 NO ESCALATION | 73,300 | MERZ B | 1 | 1 | BILL M |  | 10-028 | 11-055 | 12-029 | 12-050F |  |  |  |  |  | 10-040 |  |  |  |  |  |
| 13221010Za |  | Revised Schedule per CR11-055 Vend Fab Magnet Box Power Supplies Delivery of ARC8 |  | 164d | 2011-08-01 | 2012-03-30 | 13221010Z FS-164d | 542d | 0d | PROCUREMENT>$50K 69 NO ESCALATION | 73,300 | MERZ B | 1 | 1 | BILL M |  | 10-028 | 11-055 | 12-029 | 12-050F |  |  |  |  |  | 10-040 |  |  |  |  |  |
| 13221010Zb |  | Revised Schedule per CR11-055 Vend Fab Magnet Box Power Supplies Delivery of ARC9 |  | 164d | 2011-08-01 | 2012-03-30 | 13221010Za FS-164d | 542d | 0d | PROCUREMENT>$50K 69 NO ESCALATION | 73,300 | MERZ B | 1 | 1 | BILL M |  | 10-028 | 11-055 | 12-029 | 12-050F |  |  |  |  |  | 10-040 |  |  |  |  |  |
| 13221010Zc |  | Revised Schedule per CR11-055 Vend Fab Magnet Box Power Supplies Delivery of Final Documentation and Spare Parts |  | 164d | 2011-08-01 | 2012-03-30 | 13221010Zb FS-164d | 542d | 0d | PROCUREMENT>$50K 69 NO ESCALATION | 95,074.2 | MERZ B | 1 | 1 | BILL M |  | 10-028 | 11-055 | 12-029 | 12-050F |  |  |  |  |  | 10-040 |  |  |  |  |  |
| 13221005B |  | Vend Fab Magnet System Box Power Supplies Oversight FY12 |  | 21d | 2011-10-03 | 2011-10-31 | 13221005A | 768d | 226d | ELEC ENG [20 h] | 1,411.2 | MERZ B | 1 | 1 | BILL M |  | 10-028 | 11-055 | 12-029F | 12-050F |  | APP |  | 3221 |  | 10-040 |  |  |  |  |  |
| 13221093a |  | Rental for Dummy Load Water Skid FY12 |  | 29d | 2011-10-03 | 2011-11-10 | 13221093 | 1d |  | ELEC ENG [7.89 h]; SUPPLIES & MATERIALS | 15,261.34 | MERZ B | 1 | 1 | BILL M |  | 10-028 |  |  |  |  |  |  |  |  |  | 10-066 |  |  |  | 12-001 |
| 13221096LOE |  | Engineering Oversight - Develop/Conduct Procedures, Q.A. and Training FY12 |  | 247d | 2011-10-03 | 2012-09-28 | 13221095LOE | 227d | 0d | ELEC TECH [31.67 h]; ELEC ENG [301 h]; ELEC DES [31.67 h] | 24,235.81 | MERZ B | 1 | 1 | BILL M |  | 10-028 |  |  |  |  |  |  |  |  |  |  |  |  |  |  |
| 13221015a |  | Receive & Inpect Magnet System Box Power Supplies (Revised by CR11-055) |  | 23d | 2012-01-27 | 2012-02-29 | 13221010Zc FS-45d, 13221005B FS-172d, 13221010C | 542d | 0d | ELEC TECH [17.12 h] | 755.51 | MERZ B | 1 | 1 | BILL M |  | 10-028 | 11-055 | 12-029 | 12-050F |  |  |  |  |  | 10-040 |  |  |  |  |  |
| 13221020a |  | Place/Connect/Check-out Magnet System Box Power Supplies (Revised by CR11-055) |  | 12.42d | 2012-02-29 | 2012-03-16 | 13221015 FS-150d, 13221015a FS-1d, 13224040 | 542d | 339d | ELEC ENG [38.4 h]; ELEC DES [38.4 h]; ELEC TECH [76.8 h]; COMP SCIENT [15.36 h]; SUPPLIES & MATERIALS | 9,958.78 | MERZ B | 1 | 1 | BILL M |  | 10-028 | 11-055 | 12-029 | 12-050F |  |  |  |  |  | 10-040 |  |  |  |  |  |
| 13221022 |  | Procurement Prep for Magnet Box Power Supplies Revised per CR12-029 |  | 58d | 2012-03-01 | 2012-05-21 | 9-120M FS+98d | 20d | 0d | ELEC ENG [160 h] | 11,289.6 | MERZ B | 1 | 1 | BILL M |  | 10-028 | 11-055 | 12-029 | 12-050F |  |  |  |  |  | 10-040 |  |  |  |  |  |
| 13221021 |  | Reverse Entry Per CR12-029 |  | 10d | 2012-03-02 | 2012-03-15 | 9-120M FS+99d | 138d |  | PROCUREMENT>$50K 69 NO ESCALATION | -1,194,574.2 | MERZ B | 1 | 1 | BILL M |  | 10-028 |  | 12-029 |  |  |  |  |  |  |  |  |  |  |  |  |
| 13221025A |  | Test T&M PS |  | 64d | 2012-03-05 | 2012-06-01 | 9-120M FS+100d | 512d |  | COMP SCIENT [40 h]; ELEC TECH [80 h]; ELEC ENG [80 h] | 11,800 | MERZ B | 1 | 1 | BILL M |  |  |  |  |  |  |  |  |  |  |  |  | 12-028 |  |  |  |
| 13221125A |  | Reverse Entry Per CR 12-028 |  | 15d | 2012-03-05 | 2012-03-23 | 9-120M FS+100d | 132d |  | ELEC TECH [-40 h]; ELEC ENG [-40 h]; PROCUREMENT>$50K 69 | -106,140.78 | MERZ B | 1 | 1 | BILL M |  | 10-028 |  |  |  |  |  |  |  |  |  |  | 12-028 |  |  |  |
| 13221026 |  | Magnet Box Power Supply Original Vendor Refund |  | 15d | 2012-04-02 | 2012-04-20 | 9-120M FS+120d | 112d |  | PROCUREMENT>$50K 69; PROCUREMENT<$50K 60 | -149,000 | MERZ B | 1 | 1 | BILL M |  | 10-028 | 11-055 | 12-029 |  |  |  |  |  |  | 10-040 |  |  |  |  |  |
| 13221126M |  | Award Arc 1 and Hall A PS | milestone | 0d | 2012-04-02 | 2012-04-02 | 9-120M FS+120d | 162d | 0d |  |  | MERZ B | 1 | 1 | BILL M |  | 10-028 |  |  |  | 6 |  |  |  |  |  |  | 12-028 |  |  |  |

Notes:
- 13221090: Corrective Actions: DDM: Added Machine Shop expense / resource ($2060) back into this activity.
- 13221092: Corrective Actions: DDM: Added Machine Shop expense / resource ($2060) back into this activity.
- 13221093: Corrective Actions: DDM: Added Machine Shop expense / resource ($2060) back into this activity.
- 13221093a: Corrective Actions: DDM: Added Machine Shop expense / resource ($2060) back into this activity.

| ID | Activity | Duration | Start | Finish | Predecessors | Total float | Free float | Calendar | Resources | Cost | RESP - Responsibility | STRT%COMP for CM EVM | FNSH%COMP for CM EVM | Advance Purchase Plan > 500K | CR 08-010 | CAM RESPONSIBLE | CR 10-028 | CR 12-028 | CR 12-053 | CR 12-029 | CR 12-029A | CR 10-040 | CR 11-055 | CR 12-050 | CR 13-011 | CR 13-014 | ReBaseline Actuals Adjustment | BOE NOTES | Original Activity ID Rebaseline | BOE Labor | BOE Expenses | BOE Adder | CR 13-015 | Post Rebaseline | Over Under Fixed | EVMS Reporting Codes | BOE Procurement | Obligated Prior to Rebaseline | Temple/Lehman | CR 14-001 | CR 08-052 |
| --- | --- | --- | --- | --- | --- | --- | --- | --- | --- | --- | --- | --- | --- | --- | --- | --- | --- | --- | --- | --- | --- | --- | --- | --- | --- | --- | --- | --- | --- | --- | --- | --- | --- | --- | --- | --- | --- | --- | --- | --- | --- |
| 13221127 | Production & Delivery of Arc 1 and Hall A PS | 150d | 2012-04-02 | 2012-10-31 | 13221126M | 162d | 0d |  | PROCUREMENT>$50K 69 NO ESCALATION FY13 | 150,000 | MERZ B | 1 | 1 | APP | 08-010 | BILL M | 10-028 | 12-028 |  |  |  |  |  |  |  |  |  |  |  |  |  |  |  |  |  |  |  |  |  |  |  |
| 13221128 | Monitor Production of Arc 1 and Hall A PS FY12 | 127d | 2012-04-02 | 2012-09-28 | 13221126M | 221d | 0d |  | ELEC ENG [67.73 h] | 4,779.03 | MERZ B | 1 | 1 |  |  | BILL M | 10-028 | 12-028 | 12-053 |  |  |  |  |  |  |  |  |  |  |  |  |  |  |  |  |  |  |  |  |  |  |
| 13221021A | Additional Reverse Entry Per CR12-029A | 10d | 2012-04-03 | 2012-04-16 | 9-120M FS+121d | 116d |  |  | PROCUREMENT>$50K 69 NO ESCALATION | -169,626.8 | MERZ B | 1 | 1 |  |  | BILL M | 10-028 |  |  | 12-029 | 12-029A |  |  |  |  |  |  |  |  |  |  |  |  |  |  |  |  |  |  |  |  |
| 13221130 | Remove and Shuffle Box PS | 97d | 2012-05-14 | 2012-09-28 | 2-02M, 13221125, 13221127 FS-120d, 13221128a FS-120d, 13221120 | 221d | 59d |  | ELEC TECH [160 h]; SKLLD TRADE [80 h] | 9,736.8 | MERZ B | 1 | 1 |  |  | BILL M | 10-028 | 12-028 |  | 12-029F |  |  |  |  |  |  |  |  |  |  |  |  |  |  |  |  |  |  |  |  |  |
| 13221022a | Magnet Box Power Supply Contract Oversight FY12 | 91d | 2012-05-22 | 2012-09-28 | 13221022 | 20d | 0d |  | TRAVEL; ELEC ENG [200 h] | 18,112 | MERZ B | 1 | 1 |  |  | BILL M | 10-028 |  |  | 12-029 |  | 10-040 | 11-055 |  |  |  |  |  |  |  |  |  |  |  |  |  |  |  |  |  |  |
| 13221022D | Vend Fab Magnet Box Power Supplies Peg Point #1 - Design Review (Kick-off Meeting) | 105d | 2012-08-24 | 2013-01-31 | 13221022 FS+66d | 20d | 0d |  | PROCUREMENT>$50K 69 NO ESCALATION; PROCUREMENT<$50K 60 NO ESCALATION | 173,494 | MERZ B | 1 | 1 |  |  | BILL M | 10-028 |  |  | 12-029 |  | 10-040 | 11-055 | 12-050 | 13-011 |  |  |  |  |  |  |  |  |  |  |  |  |  |  |  |  |
| 13221023 | Vend Fab Magnet Box Power Supplies Peg Point #1A - Receipt of Materials | 167d | 2012-08-24 | 2013-04-30 | 13221022D FS-105d | 20d | 0d |  | PROCUREMENT>$50K 69 NO ESCALATION; PROCUREMENT<$50K 60 NO ESCALATION | 346,988 | MERZ B | 1 | 1 |  |  | BILL M | 10-028 |  |  | 12-029 |  | 10-040 | 11-055 | 12-050 | 13-011 |  |  |  |  |  |  |  |  |  |  |  |  |  |  |  |  |
| 13221023A | Vend Fab Magnet Box Power Supplies Peg Point #2 - First Power Supply (ARC 2) Delivered to JLab | 231d | 2012-08-24 | 2013-07-31 | 13221023 FS-167d | 20d | 0d |  |  |  | MERZ B | 1 | 1 |  |  | BILL M | 10-028 |  |  | 12-029 |  | 10-040 | 11-055 | 12-050 |  |  |  |  |  |  |  |  |  |  |  |  |  |  |  |  |  |
| 13221023B | Vend Fab Magnet Box Power Supplies Peg Point #3 - First Power Supply (ARC 2) Accepted, Tested and Production Start | 253d | 2012-08-24 | 2013-08-30 | 13221023A FS-231d | 20d |  |  | PROCUREMENT>$50K 69 NO ESCALATION | 57,000 | MERZ B | 1 | 1 |  |  | BILL M | 10-028 |  |  | 12-029 |  | 10-040 | 11-055 | 12-050 |  |  |  |  |  |  |  |  |  |  |  |  |  |  |  |  |  |
| 13221022b | Magnet Box Power Supply Contract Oversight FY13 *** Re-Baseline Split | 228d | 2012-10-01 | 2013-08-30 | 13221022a | 20d |  |  | ELEC ENG [257.42 h]; TRAVEL | 24,434.84 | MERZ B | 1 | 1 |  |  | BILL M | 10-028 |  |  | 12-029 |  | 10-040 | 11-055 |  |  | 13-014 |  |  |  |  |  |  |  |  |  |  |  |  |  |  |  |
| 13221097LOE | Engineering Oversight - Develop/Conduct Procedures, Q.A. and Training FY13 | 31d | 2012-10-01 | 2012-11-12 | 13221096LOE | 227d |  |  | ELEC ENG [37.8 h]; ELEC DES [3.98 h]; ELEC TECH [3.98 h] | 3,140.91 | MERZ B | 1 | 1 |  |  | BILL M | 10-028 |  |  |  |  |  |  |  |  |  |  |  |  |  |  |  |  |  |  |  |  |  |  |  |  |
| 13221128a | Monitor Production of Arc 1 and Hall A PS FY13 | 23d | 2012-10-01 | 2012-10-31 | 13221128 | 221d | 0d |  | ELEC ENG [12.27 h] | 893.38 | MERZ B | 1 | 1 |  |  | BILL M | 10-028 | 12-028 | 12-053 |  |  |  |  |  |  |  |  |  |  |  |  |  |  |  |  |  |  |  |  |  |  |
| 13221133 | Receive, Inspect and Install Arc 1 and Hall A PS | 36d | 2012-11-01 | 2012-12-31 | 13221127 | 162d | 0d |  | SKLLD TRADE [80 h]; ELEC TECH [160 h] | 10,048 | MERZ B | 1 | 1 |  |  | BILL M | 10-028 | 12-028 |  |  |  |  |  |  |  |  |  |  |  |  |  |  |  |  |  |  |  |  |  |  |  |
| 13221135 | Test Arc 1 and Hall A PS w/ Dummy Load | 21d | 2013-01-02 | 2013-01-31 | 13221130, 13221133 | 162d | 142d |  | ELEC TECH [196 h]; ELEC DES [64 h]; ELEC ENG [40 h] | 15,173.92 | MERZ B | 1 | 1 |  |  | BILL M | 10-028 | 12-028 |  | 12-029F |  |  |  |  |  |  |  |  |  |  |  |  |  |  |  |  |  |  |  |  |  |
| 13221024 | Receive & Inpect Magnet System Box Power Supplies (Revised by CR12-029) *** Re-Baseline Split | 22d | 2013-08-01 | 2013-08-30 | 13221023 FS-320d, 13221023A | 203d | 0d |  | ELEC TECH [11.34 h] | 516.42 | MERZ B | 1 | 1 |  |  | BILL M | 10-028 |  |  | 12-029 |  | 10-040 | 11-055 | 12-050 |  | 13-014 |  |  |  |  |  |  |  |  |  |  |  |  |  |  |  |
| 13221024a | Place/Connect/Check-out Magnet System Box Power Supplies (Revised by CR12-029) *** Re-Baseline Split | 17d | 2013-08-08 | 2013-08-30 | 13221024 FS-17d | 203d | 0d |  | ELEC TECH [95.14 h]; COMP SCIENT [19.03 h]; SUPPLIES & MATERIALS; ELEC ENG [47.57 h]; ELEC DES [47.57 h] | 12,730.1 | MERZ B | 1 | 1 |  |  | BILL M | 10-028 |  |  | 12-029 | 12-029A | 10-040 | 11-055 | 12-050 |  | 13-014 |  |  |  |  |  |  |  |  |  |  |  |  |  |  |  |
| 13221025 | Test Magnet System Box Power Supplies w/Dummy Load *** Re-Baseline Split | 12d | 2013-08-15 | 2013-08-30 | 13221092, 13221020a FS+14.58d, 3A-23M, 13221020 FS-180d, 13221024a FS-12d | 203d |  |  | ELEC TECH [71.44 h]; ELEC ENG [35.72 h]; ELEC DES [35.72 h] | 7,715.88 | MERZ B | 1 | 1 |  |  | BILL M | 10-028 |  |  | 12-029 |  | 10-040 | 11-055 | 12-050 |  | 13-014 |  |  |  |  |  |  |  |  |  |  |  |  |  |  |  |
| 13221140 | Re-Baseline Actuals Adjustment | 1d | 2013-08-30 | 2013-08-30 | 9-130M FS+227d | 20d |  |  | PROCUREMENT>$50K 69 NO ESCALATION | -32,719.25 | MERZ B | 1 | 1 |  |  | BILL M |  |  |  |  |  |  |  |  |  | 13-014 | ADJ |  |  |  |  |  |  |  |  |  |  |  |  |  |  |
| 23221022b | Magnet Box Power Supply Contract Oversight FY13 | 20d | 2013-09-03 | 2013-09-30 | 9-130M FS+228d | 17d | 0d | 8/5 M-F w/JLAB Holidays ReBaseline | ELEC ENG [32.21 h]; TRAVEL | 3,687.21 | MERZ B | 1 | 1 |  |  | BILL M | 10-028 |  |  | 12-029 |  | 10-040 | 11-055 |  |  |  |  | Extra effort to keep on schedule | 23221022b | EJ | EJ | NO | 13-015 | PR |  |  |  |  |  |  |  |
| 23221023C | Vend Fab Magnet Box Power Supplies Peg Point #4 - ARC 3, 4, 5, 6 and LAM 1 Delivered and accepted at JLab | 62d | 2013-09-03 | 2013-11-27 | 9-130M FS+228d | 154d | 0d | 8/5 M-F w/JLAB Holidays ReBaseline | PROCUREMENT>$50K 69 NO ESCALATION | 290,775 | MERZ B | 1 | 1 |  |  | BILL M | 10-028 |  |  | 12-029 |  | 10-040 | 11-055 | 12-050 |  |  |  |  | 23221023C |  |  |  | 13-015 | PR | y | D | OB | OB |  |  |  |
| 23221023D | Vend Fab Magnet Box Power Supplies Peg Point #4 *** Delivery Incentive Bonus****** | 62d | 2013-09-03 | 2013-11-27 | 23221023C FS-62d | 154d | 0d | 8/5 M-F w/JLAB Holidays ReBaseline | PROCUREMENT>$50K 69 NO ESCALATION | 80,000 | MERZ B | 1 | 1 |  |  | BILL M | 10-028 |  |  | 12-029 |  | 10-040 | 11-055 | 12-050 |  |  |  |  | 23221023D |  |  |  | 13-015 | PR | y | D | OB | OB |  |  |  |
| 23221023F | Vend Fab Magnet Box Power Supplies Peg Point #5 - ARC 7, 8, 9, 10, RSEP 8 and XSEP 10 Delivered and accepted at JLab | 161d | 2013-09-03 | 2014-04-30 | 23221023D FS-62d | 154d | 0d | 8/5 M-F w/JLAB Holidays ReBaseline | PROCUREMENT>$50K 69 NO ESCALATION | 377,630 | MERZ B | 1 | 1 |  |  | BILL M | 10-028 |  |  | 12-029 |  | 10-040 | 11-055 | 12-050 |  |  |  |  | 23221023F |  |  |  | 13-015 | PR | y | D | OB | OB |  |  |  |
| 23221023G | Vend Fab Magnet Box Power Supplies Peg Point #5 *** Delivery Incentive Bonus****** | 161d | 2013-09-03 | 2014-04-30 | 23221023F FS-161d | 154d | 0d | 8/5 M-F w/JLAB Holidays ReBaseline | PROCUREMENT>$50K 69 NO ESCALATION | 80,000 | MERZ B | 1 | 1 |  |  | BILL M | 10-028 |  |  | 12-029 |  | 10-040 | 11-055 | 12-050 |  |  |  |  | 23221023G |  |  |  | 13-015 | PR | y | D | OB | OB |  |  |  |
| 23221023H | Vend Fab Magnet Box Power Supplies Peg Point #6 - LAM 3, XSEP 8 and RSEP 9 Delivered and accepted at JLab | 182d | 2013-09-03 | 2014-05-30 | 23221023G FS-161d | 154d | 0d | 8/5 M-F w/JLAB Holidays ReBaseline | PROCUREMENT>$50K 69 NO ESCALATION | 104,565 | MERZ B | 1 | 1 |  |  | BILL M | 10-028 |  |  | 12-029 |  | 10-040 | 11-055 | 12-050 |  |  |  |  | 23221023H |  |  |  | 13-015 | PR | y | D | OB | OB |  |  |  |
| 23221023J | Vend Fab Magnet Box Power Supplies Peg Point #6 *** Delivery Incentive Bonus****** | 182d | 2013-09-03 | 2014-05-30 | 23221023H FS-182d | 154d | 0d | 8/5 M-F w/JLAB Holidays ReBaseline | PROCUREMENT>$50K 69 NO ESCALATION | 40,000 | MERZ B | 1 | 1 |  |  | BILL M | 10-028 |  |  | 12-029 |  | 10-040 | 11-055 | 12-050 |  |  |  |  | 23221023J |  |  |  | 13-015 | PR | y | D | OB | OB |  |  |  |
| 23221023K | Vend Fab Magnet Box Power Supplies Peg Point #7 Acceptance Test at JLab | 246d | 2013-09-03 | 2014-08-29 | 23221023J FS-182d | 154d | 0d | 8/5 M-F w/JLAB Holidays ReBaseline | PROCUREMENT>$50K 69 NO ESCALATION | 384,488 | MERZ B | 1 | 1 |  |  | BILL M | 10-028 |  |  | 12-029 |  | 10-040 | 11-055 | 12-050 |  |  |  |  | 23221023K |  |  |  | 13-015 | PR | y | D | OB | OB |  |  |  |
| 23221023L | Vend Fab Magnet Box Power Supplies Peg Point #8 Delivery of Spares | 246d | 2013-09-03 | 2014-08-29 | 23221023K FS-246d | 154d |  | 8/5 M-F w/JLAB Holidays ReBaseline | PROCUREMENT>$50K 69 NO ESCALATION | 53,800 | MERZ B | 1 | 1 |  |  | BILL M | 10-028 |  |  | 12-029 |  | 10-040 | 11-055 | 12-050 |  |  |  |  | 23221023L |  |  |  | 13-015 | PR | y | D | OB | OB |  |  |  |
| 23221024 | Receive & Inpect Magnet System Box Power Supplies Part A FY13 (FY14 @ 23221029) | 20d | 2013-09-03 | 2013-09-30 | 9-130M FS+228d | 0d |  | 8/5 M-F w/JLAB Holidays ReBaseline | ELEC TECH [10.68 h] | 486.37 | MERZ B | 1 | 1 |  |  | BILL M | 10-028 |  |  | 12-029 |  | 10-040 | 11-055 | 12-050 |  |  |  |  | 23221024 | PE | EJ |  | 13-015 | PR |  | U |  |  |  |  |  |
| 23221024b | Place/Connect Magnet System Box Power Supplies Part A Procurement | 62d | 2013-09-03 | 2013-11-27 | 23221024a FS-193d | 0d |  | 8/5 M-F w/JLAB Holidays ReBaseline | ELEC TECH; COMP SCIENT; SUPPLIES & MATERIALS; ELEC ENG; ELEC DES; PROCUREMENT<$50K 60 NO ESCALATION FY14 | 434.55 | MERZ B | 1 | 1 |  |  | BILL M | 10-028 |  |  | 12-029 | 12-029A | 10-040 | 11-055 | 12-050 |  |  |  |  | 23221024a | PE | EJ |  | 13-015 | PR | y | U |  | OB | LR13 |  |  |
| 23221024c | Place/Connect Magnet System Box Power Supplies Part A Labor/Expenses FY13 | 20d | 2013-09-03 | 2013-09-30 | 23221024a FS-193d | 0d |  | 8/5 M-F w/JLAB Holidays ReBaseline | ELEC TECH [114.25 h]; COMP SCIENT [22.85 h]; SUPPLIES & MATERIALS; ELEC ENG [57.12 h]; ELEC DES [57.12 h] | 15,141.7 | MERZ B | 1 | 1 |  |  | BILL M | 10-028 |  |  | 12-029 | 12-029A | 10-040 | 11-055 | 12-050 |  |  |  |  | 23221024a | PE | EJ |  | 13-015 | PR |  | U |  |  | LR13 |  |  |
| 23221127 | Production & Delivery of Arc 1 and Hall A PS | 34d | 2013-09-03 | 2013-10-18 | 9-130M FS+228d | 62d | 0d | 8/5 M-F w/JLAB Holidays ReBaseline | PROCUREMENT<$50K 60 NO ESCALATION; PROCUREMENT>$50K 69 NO ESCALATION | 70,875 | MERZ B | 1 | 1 | APP | 08-010 | BILL M | 10-028 | 12-028 |  |  |  |  |  |  |  |  |  |  | 23221127 |  |  |  | 13-015 | PR | y | U | OB | OB |  |  |  |
| 23221133 | Receive, Inspect and Install Arc 1 and Hall A PS FY13 | 20d | 2013-09-03 | 2013-09-30 | 23221127 FS-34d | 62d | 0d | 8/5 M-F w/JLAB Holidays ReBaseline | SKLLD TRADE [13.56 h]; ELEC TECH [27.12 h] | 1,703.13 | MERZ B | 1 | 1 |  |  | BILL M | 10-028 | 12-028 |  |  |  |  |  |  |  |  |  |  | 23221133 | PE | EJ |  | 13-015 | PR |  | U |  |  |  |  |  |
| 23221022c | Magnet Box Power Supply Contract Oversight FY14 | 163d | 2013-10-01 | 2014-06-02 | 23221022b | 17d |  | 8/5 M-F w/JLAB Holidays ReBaseline | ELEC ENG [160 h]; TRAVEL | 18,212.2 | MERZ B | 1 | 1 |  |  | BILL M | 10-028 |  |  | 12-029 |  | 10-040 | 11-055 |  |  |  |  | Extra effort to keep on schedule | 23221022c | EJ | EJ | NO | 13-015 | PR |  |  |  |  |  | 14-001 |  |
| 23221024d | Place/Connect Magnet System Box Power Supplies Part A Labor/Expenses FY14 | 42d | 2013-10-01 | 2013-11-27 | 23221024a FS-193d, 23221024c | 0d |  | 8/5 M-F w/JLAB Holidays ReBaseline | ELEC TECH [239.91 h]; COMP SCIENT [47.98 h]; SUPPLIES & MATERIALS; ELEC ENG [119.96 h]; ELEC DES [119.96 h] | 32,810.38 | MERZ B | 1 | 1 |  |  | BILL M | 10-028 |  |  | 12-029 | 12-029A | 10-040 | 11-055 | 12-050 |  |  |  |  | 23221024a | PE | EJ |  | 13-015 | PR |  | U |  |  | LR13 | 14-001 |  |
| 23221029 | Receive & Inpect Magnet System Box Power Supplies Part A FY14 (FY13 @ 23221024) | 42d | 2013-10-01 | 2013-11-27 | 9-130M FS+228d, 23221024 | 0d |  | 8/5 M-F w/JLAB Holidays ReBaseline | ELEC TECH [22.42 h] | 1,053.52 | MERZ B | 1 | 1 |  |  | BILL M | 10-028 |  |  | 12-029 |  | 10-040 | 11-055 | 12-050 |  |  |  |  | 23221024 | PE | EJ |  | 13-015 | PR |  | U |  |  |  | 14-001 |  |
| 23221133a | Receive, Inspect and Install Arc 1 and Hall A PS FY14 | 39d | 2013-10-01 | 2013-11-22 | 23221127 FS-34d, 23221133 | 62d | 0d | 8/5 M-F w/JLAB Holidays ReBaseline | SKLLD TRADE [26.44 h]; ELEC TECH [52.88 h] | 3,426.62 | MERZ B | 1 | 1 |  |  | BILL M | 10-028 | 12-028 |  |  |  |  |  |  |  |  |  |  | 23221133 | PE | EJ |  | 13-015 | PR |  | U |  |  |  | 14-001 |  |
| 23221140LOE | Proj Admin ongoing FY14 Part A | 42d | 2013-10-01 | 2013-11-27 | 232111914LOE | 58d | 0d | 8/5 M-F w/JLAB Holidays ReBaseline | SR STAFF [74.82 h] | 9,002.34 | MERZ B | 1 | 1 |  |  | BILL M |  |  |  |  |  |  |  |  |  |  |  |  | 23221140LOE | EJ |  |  | 13-015 | PR |  | E |  |  |  | 14-001 | 08-052 |
| 23221023Da | DeObligation of Vend Fab Magnet Box Power Supplies Peg Point #4 *** Delivery Incentive Bonus **** | 1d | 2013-11-27 | 2013-11-27 | 23221023D FS-1d | 263d |  | 8/5 M-F w/JLAB Holidays ReBaseline | PROCUREMENT>$50K 69 NO ESCALATION | -80,000 | MERZ B | 1 | 1 |  |  | BILL M | 10-028 |  |  | 12-029 |  | 10-040 | 11-055 | 12-050 |  |  |  |  | 23221023D |  |  |  | 13-015 | PR |  | D | OB |  |  |  |  |
| 23221024a | Receive & Inpect Magnet System Box Power Supplies Part B | 131d | 2013-12-02 | 2014-06-16 | 23221024, 23221029 | 0d |  | 8/5 M-F w/JLAB Holidays ReBaseline | ELEC TECH [59.45 h] | 2,793.56 | MERZ B | 1 | 1 |  |  | BILL M | 10-028 |  |  | 12-029 |  | 10-040 | 11-055 | 12-050 |  |  |  |  | 23221024 | PE | EJ |  | 13-015 | PR |  | U |  |  |  | 14-001 |  |
| 23221024ba | Place/Connect Magnet System Box Power Supplies Part B | 136d | 2013-12-02 | 2014-06-23 | 23221024c, 23221024b, 23221024d | 0d |  | 8/5 M-F w/JLAB Holidays ReBaseline | ELEC TECH [659.87 h]; COMP SCIENT [131.97 h]; SUPPLIES & MATERIALS; ELEC ENG [329.94 h]; ELEC DES [329.94 h] | 90,524.13 | MERZ B | 1 | 1 |  |  | BILL M | 10-028 |  |  | 12-029 | 12-029A | 10-040 | 11-055 | 12-050 |  |  |  |  | 23221024a | PE | EJ |  | 13-015 | PR |  | U |  |  | LR13 | 14-001 |  |
| 23221140LOEa | Proj Admin ongoing FY14 Part B | 205d | 2013-12-02 | 2014-09-30 | 23221140LOE | 58d |  | 8/5 M-F w/JLAB Holidays ReBaseline | SR STAFF [310.41 h] | 37,348.53 | MERZ B | 1 | 1 |  |  | BILL M |  |  |  |  |  |  |  |  |  |  |  |  | 23221140LOE | EJ |  |  | 13-015 | PR |  | E |  |  |  | 14-001 | 08-052 |
| 23221023Ga | Partial DeObligation of Vend Fab Magnet Box Power Supplies Peg Point #5 *** Delivery Incentive Bonus****** | 1d | 2014-04-30 | 2014-04-30 | 23221023G FS-1d | 164d |  | 8/5 M-F w/JLAB Holidays ReBaseline | PROCUREMENT>$50K 69 NO ESCALATION | -40,000 | MERZ B | 1 | 1 |  |  | BILL M | 10-028 |  |  | 12-029 |  | 10-040 | 11-055 | 12-050 |  |  |  |  | 23221023G |  |  |  | 13-015 | PR |  | D | OB |  |  |  |  |

| ID | WBS | Activity | Type | Duration | Start | Finish | Predecessors | Total float | Free float | Calendar | Resources | Cost | RESP - Responsibility | STRT%COMP for CM EVM | FNSH%COMP for CM EVM | CAM RESPONSIBLE | CR 10-028 | CR 12-028 | CR 12-029 | CR 11-001 | CR 12-001 | CR 12-053 | CR 13-014 | ReBaseline Actuals Adjustment | Original Activity ID Rebaseline | EVMS Reporting Codes | BOE Labor | BOE Expenses | CR 13-015 | Post Rebaseline | Over Under Fixed | Obligated Prior to Rebaseline |
| --- | --- | --- | --- | --- | --- | --- | --- | --- | --- | --- | --- | --- | --- | --- | --- | --- | --- | --- | --- | --- | --- | --- | --- | --- | --- | --- | --- | --- | --- | --- | --- | --- |
|  | 2 | **1.3.2.2.2 SHUNTS** |  |  | 2010-05-13 | 2014-02-03 |  |  |  |  |  |  |  |  |  |  |  |  |  |  |  |  |  |  |  |  |  |  |  |  |  |  |
| 13222000M |  | Start Shunt Work | milestone | 0d | 2010-05-13 | 2010-05-13 | 9-100M FS+150d | 815d | 36d |  |  |  | MERZ B | 1 | 1 | BILL M | 10-028 | 12-028F | 12-029F |  |  |  |  |  |  |  |  |  |  |  |  |  |
| 13222005 |  | Engineering, Drafting and Software - Single Channel Shunt Chassis |  | 20d | 2010-07-06 | 2010-08-02 | 9-100M FS+186d, 13222000M | 779d | 0d |  | ELEC ENG [40 h]; ELEC DES [40 h]; COMP SCIENT [40 h] | 7,013.2 | MERZ B | 1 | 1 | BILL M | 10-028 | 12-028F | 12-029F |  |  |  |  |  |  |  |  |  |  |  |  |  |
| 13222020 |  | Procurements Parts and Boards - Single Channel Shunt Chassis |  | 50d | 2010-07-15 | 2010-09-23 | 13222015 FS-55d | 779d | 0d |  | PROCUREMENT<$50K 60 | 20,200 | MERZ B | 1 | 1 | BILL M | 10-028 | 12-028F | 12-029F |  |  |  |  |  |  |  |  |  |  |  |  |  |
| 13222015 |  | Labor and Expenses - Single Channel Shunt Chassis |  | 52d | 2010-07-20 | 2010-09-30 | 13222005 FS-10d | 779d | 0d |  | MSHOP; ELEC TECH [16 h] | 3,163.2 | MERZ B | 1 | 1 | BILL M | 10-028 | 12-028F | 12-029F |  |  |  |  |  |  |  |  |  |  |  |  |  |
| 13222040 |  | Engineering and Drafting - Shunt Resistor Plates |  | 8d | 2010-08-02 | 2010-08-11 | 9-100M FS+205d | 806d | 0d |  | ELEC DES [24 h]; ELEC ENG [40 h] | 3,789.36 | MERZ B | 1 | 1 | BILL M | 10-028 |  | 12-029F |  |  |  |  |  |  |  |  |  |  |  |  |  |
| 13222045 |  | Labor and Expenses - Shunt Resistor Plates FY10 |  | 35d | 2010-08-12 | 2010-09-30 | 13222040 | 806d | 0d |  | ELEC TECH [23.33 h]; MSHOP | 5,342.03 | MERZ B | 1 | 1 | BILL M | 10-028 |  | 12-029F | 11-001 |  |  |  |  |  |  |  |  |  |  |  |  |
| 13222050 |  | Procurement (Parts) - Shunt Resistor Plates |  | 55d | 2010-08-19 | 2010-11-04 | 13222045a FS-55d | 806d | 0d |  | PROCUREMENT<$50K 60 NO ESCALATION FY11 | 28,000 | MERZ B | 1 | 1 | BILL M | 10-028 |  | 12-029F |  |  |  |  |  |  |  |  |  |  |  |  |  |
| 13222025 |  | Assembly and Testing - Single Channel Shunt Chassis FY10 |  | 5d | 2010-09-24 | 2010-09-30 | 13222020 | 779d | 0d |  | ELEC TECH [25.71 h] | 1,065.68 | MERZ B | 1 | 1 | BILL M | 10-028 | 12-028F | 12-029F | 11-001 |  |  |  |  |  |  |  |  |  |  |  |  |
| 13222025a |  | Assembly and Testing - Single Channel Shunt Chassis FY11 |  | 65d | 2010-10-01 | 2011-01-11 | 13222025 | 779d | 430d |  | ELEC TECH [334.29 h] | 14,297.58 | MERZ B | 1 | 1 | BILL M | 10-028 | 12-028F | 12-029F | 11-001 |  |  |  |  |  |  |  |  |  |  |  |  |
| 13222045a |  | Labor and Expenses - Shunt Resistor Plates FY11 |  | 25d | 2010-10-01 | 2010-11-04 | 13222045 | 806d | 0d |  | ELEC TECH [16.67 h]; MSHOP | 3,937.67 | MERZ B | 1 | 1 | BILL M | 10-028 |  | 12-029F | 11-001 |  |  |  |  |  |  |  |  |  |  |  |  |
| 13222055 |  | Assembly and Testing - Shunt Resistor Plates |  | 70d | 2010-11-05 | 2011-02-24 | 13222045a, 13222050 | 806d | 55d |  | ELEC TECH [210 h] | 8,981.7 | MERZ B | 1 | 1 | BILL M | 10-028 |  | 12-029F |  |  |  |  |  |  |  |  |  |  |  |  |  |
| 13222070 |  | Engineering, Drafting and Software - Track Regulator and 30/80 Frozen Per CR 12-028 |  | 50d | 2011-01-25 | 2011-04-05 | 9-110M FS+73d | 681d | 0d |  | COMP SCIENT [40 h]; ELEC ENG [160 h]; ELEC DES [160 h] | 21,316.4 | MERZ B | 1 | 1 | BILL M | 10-028 |  | 12-029F |  |  |  |  |  |  |  |  |  |  |  |  |  |
| 13222075 |  | Oversight (Labor) - Track Regulator and 30/80 Frozen Per CR 12-028 |  | 40d | 2011-03-23 | 2011-05-17 | 13222070 FS-10d | 681d | 0d |  | ELEC TECH [40 h] | 1,710.8 | MERZ B | 1 | 1 | BILL M | 10-028 |  | 12-029F |  |  |  |  |  |  |  |  |  |  |  |  |  |
| 13222080 |  | Procurement (Parts) - Track Regulator and 30/80 Frozen Per CR 12-028 |  | 35d | 2011-03-30 | 2011-05-17 | 13222075 FS-35d | 681d | 0d |  | PROCUREMENT<$50K 60 | 34,362.27 | MERZ B | 1 | 1 | BILL M | 10-028 |  | 12-029F |  |  |  |  |  |  |  |  |  |  |  |  |  |
| 13222060 |  | Installation - Shunt Resistor Plates Frozen per CR12-028 |  | 20d | 2011-05-13 | 2011-06-10 | 13222055, 4A-01M | 751d | 0d |  | ELEC TECH [80 h] | 3,421.6 | MERZ B | 1 | 1 | BILL M | 10-028 |  | 12-029F |  |  |  |  |  |  |  |  |  |  |  |  |  |
| 13222085 |  | Assembly and Testing - Track Regulator and 30/80 Frozen Per CR 12-028 |  | 68d | 2011-05-18 | 2011-08-23 | 13222080 | 681d | 0d |  | ELEC TECH [272 h] | 11,633.44 | MERZ B | 1 | 1 | BILL M | 10-028 |  | 12-029F |  |  |  |  |  |  |  |  |  |  |  |  |  |
| 13222145 |  | Engineering (Design) - Shunt Adder System Removal |  | 3d | 2011-06-06 | 2011-06-08 | 9-110M FS+165d | 725d | 244d |  | ELEC TECH [24 h] | 1,026.48 | MERZ B | 1 | 1 | BILL M | 10-028 |  | 12-029F |  |  |  |  |  |  |  |  |  |  |  |  |  |
| 13222065 |  | Update Machine Documentation - Shunt Resistor Plates Frozen Per CR 12-028 |  | 3d | 2011-06-13 | 2011-06-15 | 13222060 | 751d |  |  | ELEC TECH [24 h] | 1,026.48 | MERZ B | 1 | 1 | BILL M | 10-028 |  | 12-029F |  |  |  |  |  |  |  |  |  |  |  |  |  |
| 13222105 |  | Engineering, Drafting and Software - 75 Amp Shunt Upgrade |  | 5d | 2011-08-23 | 2011-08-29 | 9-110M FS+220d | 604d | 0d |  | ELEC DES [8 h]; COMP SCIENT [80 h]; ELEC ENG [32 h] | 7,666.96 | MERZ B | 1 | 1 | BILL M | 10-028 | 12-028F | 12-029F |  |  |  |  |  |  |  |  |  |  |  |  |  |
| 13222090 |  | Installation and Testing - Track Regulator and 30/80 Frozen Per CR 12-028 |  | 20d | 2011-08-24 | 2011-09-21 | 13222085 | 681d | 0d |  | ELEC TECH [80 h] | 3,421.6 | MERZ B | 1 | 1 | BILL M | 10-028 |  | 12-029F |  |  |  |  |  |  |  |  |  |  |  |  |  |
| 13222110 |  | Oversight (Labor) - 75 Amp Shunt Upgrade |  | 15d | 2011-08-30 | 2011-09-20 | 13222105 | 604d | 0d |  | ELEC TECH [40 h] | 1,710.8 | MERZ B | 1 | 1 | BILL M | 10-028 | 12-028F | 12-029F |  |  |  |  |  |  |  |  |  |  |  |  |  |
| 13222115 |  | Procurement (Parts) - 75 Amp Shunt Upgrade |  | 10d | 2011-09-07 | 2011-09-20 | 13222110 FS-10d | 604d | 0d |  | PROCUREMENT<$50K 60 | 309.57 | MERZ B | 1 | 1 | BILL M | 10-028 | 12-028F | 12-029F |  |  |  |  |  |  |  |  |  |  |  |  |  |
| 13222120 |  | Modifications and Testing - 75 Amp Shunt Upgrade FY11 |  | 8d | 2011-09-21 | 2011-09-30 | 13222115 | 604d | 0d |  | ELEC TECH [62.48 h] | 2,672.27 | MERZ B | 1 | 1 | BILL M | 10-028 | 12-028F | 12-029F |  | 12-001 |  |  |  |  |  |  |  |  |  |  |  |
| 13222100 |  | Data Entry/Paperwork - Track Regulator and 30/80 Frozen Per CR 12-028 |  | 2d | 2011-09-22 | 2011-09-23 | 13222090 | 681d |  |  | ELEC TECH [16 h] | 684.32 | MERZ B | 1 | 1 | BILL M | 10-028 |  | 12-029F |  |  |  |  |  |  |  |  |  |  |  |  |  |
| 13222120a |  | Modifications and Testing - 75 Amp Shunt Upgrade FY12 |  | 13d | 2011-10-03 | 2011-10-19 | 13222120 | 604d | 0d |  | ELEC TECH [101.52 h] | 4,480.08 | MERZ B | 1 | 1 | BILL M | 10-028 | 12-028F | 12-029F |  | 12-001 |  |  |  |  |  |  |  |  |  |  |  |
| 13222125 |  | Installation and Testing - 75 Amp Shunt Upgrade Part A |  | 10d | 2011-10-20 | 2011-11-02 | 13222120a | 651d | 0d |  | ELEC TECH [80 h] | 3,530.4 | MERZ B | 1 | 1 | BILL M | 10-028 |  | 12-029F |  |  |  |  |  |  |  |  |  |  |  |  |  |
| 13222140 |  | Update Machine Documentation - 75 Amp Shunt Upgrade Part A |  | 2d | 2011-11-03 | 2011-11-04 | 13222125 | 651d |  |  | ELEC DES [8 h]; ELEC TECH [8 h] | 757.12 | MERZ B | 1 | 1 | BILL M | 10-028 |  | 12-029F |  |  |  |  |  |  |  |  |  |  |  |  |  |
| 13222061 |  | Reverse Entry per CR12-028 |  | 15d | 2012-03-05 | 2012-03-23 | 9-120M FS+100d | 132d |  |  | ELEC ENG [-80 h]; PROCUREMENT<$50K 60; ELEC DES [-80 h]; ELEC TECH [-492 h]; COMP SCIENT [-20 h] | -46,454.87 | MERZ B | 1 | 1 | BILL M | 10-028 | 12-028 |  |  |  |  |  |  |  |  |  |  |  |  |  |  |
| 13222070A |  | Engineering, Drafting and Software - Track Regulator and 30/80 Revised Per CR 12-028 |  | 147d | 2012-03-05 | 2012-09-28 | 9-120M FS+100d | 259d | 0d |  | COMP SCIENT [60 h]; ELEC ENG [80 h]; ELEC DES [80 h] | 13,622.8 | MERZ B | 1 | 1 | BILL M | 10-028 | 12-028 |  |  |  |  |  |  |  |  |  |  |  |  |  |  |
| 13222165 |  | Engineering and Drafting - 12GEV Shunt Shuffle |  | 40d | 2012-03-12 | 2012-05-04 | 9-120M FS+105d | 385d | 0d |  | ELEC ENG [160 h]; ELEC DES [160 h] | 19,371.2 | MERZ B | 1 | 1 | BILL M | 10-028 | 12-028 | 12-029F |  |  |  |  |  |  |  |  |  |  |  |  |  |
| 13222200 |  | Engineering, Drafting and Software - 25 Amp Shunts |  | 68d | 2012-03-26 | 2012-06-29 | 9-120M FS+115d | 330d | 0d |  | ELEC ENG [80 h] | 5,644.8 | MERZ B | 1 | 1 | BILL M | 10-028 | 12-028 | 12-029F |  |  |  |  |  |  |  |  |  |  |  |  |  |
| 13222063 |  | Installation - Shunt Resistor Plates Part A |  | 103d | 2012-05-04 | 2012-09-28 | 9-120M FS+144d | 284d | 0d |  | ELEC TECH [120 h] | 5,295.6 | MERZ B | 1 | 1 | BILL M | 10-028 | 12-028 |  |  |  |  |  |  |  |  |  |  |  |  |  |  |
| 13222185 |  | New Screens for 12 GEV Shunts |  | 5d | 2012-05-07 | 2012-05-11 | 13222165 | 478d | 178d |  | COMP SCIENT [40 h] | 2,624.8 | MERZ B | 1 | 1 | BILL M | 10-028 |  | 12-029F |  |  |  |  |  |  |  |  |  |  |  |  |  |
| 13222150 |  | Component Removal - Shunt Adder System Removal |  | 7d | 2012-06-05 | 2012-06-13 | 2-02M FS+14d, 13222145 | 481d | 0d |  | ELEC TECH [40 h] | 1,765.2 | MERZ B | 1 | 1 | BILL M | 10-028 |  | 12-029F |  |  |  |  |  |  |  |  |  |  |  |  |  |
| 13222170 |  | Pull and Modify - 12GEV Shunt Shuffle |  | 59d | 2012-06-06 | 2012-08-27 | 13222165 FS+20d | 385d | 0d |  | ELEC TECH [200 h]; ELEC ENG [20 h] | 10,237.2 | MERZ B | 1 | 1 | BILL M | 10-028 | 12-028 | 12-029F |  |  |  |  |  |  |  |  |  |  |  |  |  |
| 13222155 |  | Reconfiguration and Testing - Shunt Adder System Removal |  | 7d | 2012-06-14 | 2012-06-22 | 13222150 | 481d | 0d |  | ELEC TECH [36 h] | 1,588.68 | MERZ B | 1 | 1 | BILL M | 10-028 |  | 12-029F |  |  |  |  |  |  |  |  |  |  |  |  |  |
| 13222205 |  | Procurement Labor - 25 Amp Shunts FY12 |  | 64d | 2012-07-02 | 2012-09-28 | 13222200 | 330d | 0d |  | ELEC ENG [29.43 h] | 2,076.58 | MERZ B | 1 | 1 | BILL M | 10-028 | 12-028 | 12-029F |  |  | 12-053 |  |  |  |  |  |  |  |  |  |  |
| 13222210 |  | Procurements - 25 Amp Shunts |  | 87d | 2012-07-02 | 2012-10-31 | 13222205a FS-87d, 13222200 | 330d | 0d |  | PROCUREMENT<$50K 60 NO ESCALATION FY13 | 6,000 | MERZ B | 1 | 1 | BILL M | 10-028 | 12-028 | 12-029F |  |  |  |  |  |  |  |  |  |  |  |  |  |
| 13222160 |  | Update Machine Documentation - Shunt Adder System RemovalNew Activity |  | 2d | 2012-07-16 | 2012-07-17 | 13222155 FS+15d | 481d |  |  | ELEC TECH [16 h] | 706.08 | MERZ B | 1 | 1 | BILL M | 10-028 |  | 12-029F |  |  |  |  |  |  |  |  |  |  |  |  |  |
| 13222175 |  | Clean and Modify Racks - 12GEV Shunts |  | 9d | 2012-08-28 | 2012-09-10 | 13222170 | 385d | 0d |  | ELEC TECH [80 h] | 3,530.4 | MERZ B | 1 | 1 | BILL M | 10-028 | 12-028 | 12-029F |  |  |  |  |  |  |  |  |  |  |  |  |  |
| 13222180 |  | Reinstall Chassis' in Racks - 12GEV Shunts |  | 10d | 2012-09-11 | 2012-09-24 | 13222175, 13222170 | 385d | 85d |  | ELEC TECH [80 h] | 3,530.4 | MERZ B | 1 | 1 | BILL M | 10-028 | 12-028 | 12-029F |  |  |  |  |  |  |  |  |  |  |  |  |  |
| 13222030 |  | Installation and Testing - Single Channel Shunt Chassis |  | 80d | 2012-10-01 | 2013-01-31 | 9-130M, 2-02M, 13222025a | 349d | 0d |  | ELEC TECH [80 h] | 3,643.2 | MERZ B | 1 | 1 | BILL M | 10-028 | 12-028 | 12-029F |  |  |  |  |  |  |  |  |  |  |  |  |  |
| 13222064 |  | Installation - Shunt Resistor Plates Part B |  | 142d | 2012-10-01 | 2013-04-30 | 13222063 | 284d | 0d |  | ELEC TECH [280 h] | 12,751.2 | MERZ B | 1 | 1 | BILL M | 10-028 | 12-028 |  |  |  |  |  |  |  |  |  |  |  |  |  |  |
| 13222075A |  | Oversight (Labor) - Track Regulator and 30/80 Revised Per CR 12-028 |  | 59d | 2012-10-01 | 2012-12-31 | 13222070A | 259d | 0d |  | ELEC TECH [20 h] | 910.8 | MERZ B | 1 | 1 | BILL M | 10-028 | 12-028 |  |  |  |  |  |  |  |  |  |  |  |  |  |  |
| 13222080A |  | Procurement (Parts) - Track Regulator and 30/80 Revised Per CR 12-028 |  | 59d | 2012-10-01 | 2012-12-31 | 13222075A FS-59d | 259d | 0d |  | PROCUREMENT<$50K 60 | 14,183.37 | MERZ B | 1 | 1 | BILL M | 10-028 | 12-028 |  |  |  |  |  |  |  |  |  |  |  |  |  |  |
| 13222130 |  | Installation and Testing - 75 Amp Shunt Upgrade Part B |  | 43d | 2012-10-01 | 2012-11-30 | 13222120a, 9-130M | 370d | 0d |  | ELEC TECH [40 h] | 1,821.6 | MERZ B | 1 | 1 | BILL M | 10-028 | 12-028 |  |  |  |  |  |  |  |  |  |  |  |  |  |  |
| 13222205a |  | Procurement Labor - 25 Amp Shunts FY13 |  | 23d | 2012-10-01 | 2012-10-31 | 13222205 | 330d | 0d |  | ELEC ENG [10.57 h] | 769.6 | MERZ B | 1 | 1 | BILL M | 10-028 | 12-028 | 12-029F |  |  | 12-053 |  |  |  |  |  |  |  |  |  |  |
| 13222215 |  | Modification - 25 Amp Shunt Upgrade |  | 25d | 2012-10-25 | 2012-11-30 | 13222210 FS-5d | 330d | 0d |  | ELEC TECH [160 h]; ELEC ENG [40 h] | 10,198.8 | MERZ B | 1 | 1 | BILL M | 10-028 | 12-028 | 12-029F |  |  |  |  |  |  |  |  |  |  |  |  |  |
| 13222035 |  | Data Entry / Paperwork - Single Channel Shunt Chassis |  | 57d | 2012-11-01 | 2013-01-31 | 13222030 FS-57d | 349d |  |  | COMP SCIENT [8 h]; ELEC DES [8 h] | 958.64 | MERZ B | 1 | 1 | BILL M | 10-028 | 12-028 | 12-029F |  |  |  |  |  |  |  |  |  |  |  |  |  |
| 13222142 |  | Update Machine Documentation - 75 Amp Shunt Upgrade Part B |  | 16d | 2012-12-03 | 2012-12-31 | 13222130 | 370d |  |  | ELEC DES [8 h] | 416.96 | MERZ B | 1 | 1 | BILL M | 10-028 | 12-028 |  |  |  |  |  |  |  |  |  |  |  |  |  |  |
| 13222220 |  | Installation and Testing - 25 Amp Shunt Upgrade |  | 37d | 2012-12-03 | 2013-01-31 | 13222215 | 330d | 0d |  | ELEC TECH [40 h]; ELEC ENG [40 h] | 4,734 | MERZ B | 1 | 1 | BILL M | 10-028 | 12-028 | 12-029F |  |  |  |  |  |  |  |  |  |  |  |  |  |
| 13222085A |  | Assembly and Testing - Track Regulator and 30/80 Revised Per CR 12-028 |  | 68d | 2013-01-02 | 2013-04-09 | 13222080A | 259d | 0d |  | ELEC TECH [160 h]; ELEC ENG [80 h]; ELEC DES [32 h] | 14,779.04 | MERZ B | 1 | 1 | BILL M | 10-028 | 12-028 |  |  |  |  |  |  |  |  |  |  |  |  |  |  |
| 13222230 |  | Drafting (Update Machine Drawings) |  | 19d | 2013-02-01 | 2013-02-28 | 13222220 | 330d |  |  | ELEC DES [80 h]; ELEC ENG [8 h] | 4,752.08 | MERZ B | 1 | 1 | BILL M | 10-028 | 12-028 | 12-029F |  |  |  |  |  |  |  |  |  |  |  |  |  |
| 13222190 |  | Reconfiguration and Testing - 12GEV Shunts |  | 40d | 2013-02-04 | 2013-04-01 | 13224085C, 13222185, 13222180, 13224087 | 300d | 0d |  | ELEC TECH [160 h] | 7,286.4 | MERZ B | 1 | 1 | BILL M | 10-028 | 12-028 | 12-029F |  |  |  |  |  |  |  |  |  |  |  |  |  |
| 13222195 |  | Update Machine Documentation - 12GEV Shunts |  | 8d | 2013-04-02 | 2013-04-11 | 13222190 | 300d |  |  | ELEC DES [40 h]; ELEC ENG [20 h] | 3,541 | MERZ B | 1 | 1 | BILL M | 10-028 | 12-028 | 12-029F |  |  |  |  |  |  |  |  |  |  |  |  |  |
| 13222095 |  | Installation and Testing - Track Regulator and 30/80 Revised Per CR 12-028 |  | 20d | 2013-04-10 | 2013-05-07 | 13222085A | 259d | 0d |  | ELEC TECH [40 h]; ELEC ENG [40 h] | 4,734 | MERZ B | 1 | 1 | BILL M | 10-028 | 12-028 |  |  |  |  |  |  |  |  |  |  |  |  |  |  |
| 13222067 |  | Update Machine Documentation - Shunt Resistor Plates Revised Per CR 12-028 |  | 3d | 2013-05-01 | 2013-05-03 | 13222064 | 284d |  |  | ELEC TECH [24 h] | 1,092.96 | MERZ B | 1 | 1 | BILL M | 10-028 | 12-028 |  |  |  |  |  |  |  |  |  |  |  |  |  |  |
| 13222100A |  | Data Entry/Paperwork - Track Regulator and 30/80 Revised Per CR 12-028 |  | 23d | 2013-05-08 | 2013-06-10 | 13222095 | 259d |  |  | ELEC DES [16 h] | 833.92 | MERZ B | 1 | 1 | BILL M | 10-028 | 12-028 |  |  |  |  |  |  |  |  |  |  |  |  |  |  |
| 13222240 |  | Re-Baseline Actuals Adjustment |  | 1d | 2013-08-30 | 2013-08-30 | 9-130M FS+227d | 20d |  |  | PROCUREMENT>$50K 69 NO ESCALATION | 174,521.87 | MERZ B | 1 | 1 | BILL M |  |  |  |  |  |  | 13-014 | ADJ |  |  |  |  |  |  |  |  |
| 23222030 |  | Installation and Testing - Single Channel Shunt Chassis FY13 |  | 20d | 2013-09-03 | 2013-09-30 | 9-130M FS+228d | 156d | 0d | 8/5 M-F w/JLAB Holidays ReBaseline | ELEC TECH [9.09 h] | 413.96 | MERZ B | 1 | 1 | BILL M | 10-028 | 12-028 | 12-029F |  |  |  |  |  | 23222030 | U | PE | EJ | 13-015 | PR |  |  |
| 23222035 |  | Data Entry / Paperwork - Single Channel Shunt Chassis FY13 |  | 20d | 2013-09-03 | 2013-09-30 | 23222030a FS-44d, 23222030 FS-44d | 156d | 0d | 8/5 M-F w/JLAB Holidays ReBaseline | COMP SCIENT [0.91 h]; ELEC DES [0.91 h] | 109.05 | MERZ B | 1 | 1 | BILL M | 10-028 | 12-028 | 12-029F |  |  |  |  |  | 23222035 | H | PE | EJ | 13-015 | PR |  |  |
| 23222064 |  | Installation - Shunt Resistor Plates Part A FY13 |  | 20d | 2013-09-03 | 2013-09-30 | 9-130M FS+228d | 102d | 0d | 8/5 M-F w/JLAB Holidays ReBaseline | ELEC TECH [5.71 h] | 260.03 | MERZ B | 1 | 1 | BILL M | 10-028 | 12-028 |  |  |  |  |  |  | 23222064 | U | PE | EJ | 13-015 | PR |  |  |
| 23222067 |  | Update Machine Documentation - Shunt Resistor Plates Part A FY13 |  | 20d | 2013-09-03 | 2013-09-30 | 23222064a FS-98d | 102d | 0d | 8/5 M-F w/JLAB Holidays ReBaseline | ELEC TECH [4.9 h] | 223.15 | MERZ B | 1 | 1 | BILL M | 10-028 | 12-028 |  |  |  |  |  |  | 23222067 | H | PE | EJ | 13-015 | PR |  |  |
| 23222070A |  | Engineering, Drafting and Software - Track Regulator and 30/80 Part A FY13 |  | 20d | 2013-09-03 | 2013-09-30 | 9-130M FS+228d | 101d | 0d | 8/5 M-F w/JLAB Holidays ReBaseline | ELEC DES [3.23 h]; COMP SCIENT [1.62 h]; ELEC ENG [4.85 h] | 631.11 | MERZ B | 1 | 1 | BILL M | 10-028 | 12-028 |  |  |  |  |  |  | 23222070A | S | EJ | EJ | 13-015 | PR |  |  |
| 23222075A |  | Oversight (Labor) - Track Regulator and 30/80 FY13 |  | 20d | 2013-09-03 | 2013-09-30 | 23222070Aa FS-99d | 101d | 0d | 8/5 M-F w/JLAB Holidays ReBaseline | ELEC ENG [8.08 h] | 588.3 | MERZ B | 1 | 1 | BILL M | 10-028 | 12-028 |  |  |  |  |  |  | 23222075A | S | EJ | EJ | 13-015 | PR |  |  |
| 23222080A |  | Procurement (Parts) - Track Regulator and 30/80 Part A Procurement |  | 62d | 2013-09-03 | 2013-11-27 | 23222075Aa FS-99d | 101d | 0d | 8/5 M-F w/JLAB Holidays ReBaseline | SUPPLIES & MATERIALS; PROCUREMENT<$50K 60 NO ESCALATION FY14 | 12 | MERZ B | 1 | 1 | BILL M | 10-028 | 12-028 |  |  |  |  |  |  | 23222080A | D | EJ | EJ | 13-015 | PR | y | OB |
| 23222080Ab |  | Procurement (Parts) - Track Regulator and 30/80 Part A Expenses FY13 |  | 20d | 2013-09-03 | 2013-09-30 | 23222075Aa FS-99d | 101d | 0d | 8/5 M-F w/JLAB Holidays ReBaseline | SUPPLIES & MATERIALS | 286.53 | MERZ B | 1 | 1 | BILL M | 10-028 | 12-028 |  |  |  |  |  |  | 23222080A | D | EJ | EJ | 13-015 | PR |  |  |
| 23222085A |  | Assembly and Testing - Track Regulator and 30/80 Part A FY13 |  | 20d | 2013-09-03 | 2013-09-30 | 23222080Aa FS-99d | 101d | 0d | 8/5 M-F w/JLAB Holidays ReBaseline | ELEC TECH [44.44 h] | 2,023.8 | MERZ B | 1 | 1 | BILL M | 10-028 | 12-028 |  |  |  |  |  |  | 23222085A | S | EJ | EJ | 13-015 | PR |  |  |
| 23222170 |  | Pull and Modify - 12GEV Shunt Shuffle FY13 |  | 20d | 2013-09-03 | 2013-09-30 | 9-130M FS+228d | 156d | 0d | 8/5 M-F w/JLAB Holidays ReBaseline | ELEC TECH [50.91 h] | 2,318.44 | MERZ B | 1 | 1 | BILL M | 10-028 | 12-028 | 12-029F |  |  |  |  |  | 23222170 | U | PE | EJ | 13-015 | PR |  |  |

| ID | Activity | Duration | Start | Finish | Predecessors | Total float | Free float | Calendar | Resources | Cost | Original Activity ID Rebaseline | RESP - Responsibility | STRT%COMP for CM EVM | FNSH%COMP for CM EVM | EVMS Reporting Codes | CAM RESPONSIBLE | CR 10-028 | CR 12-028 | CR 12-029 | BOE Labor | BOE Expenses | CR 13-015 | Post Rebaseline | CR 14-001 |
| --- | --- | --- | --- | --- | --- | --- | --- | --- | --- | --- | --- | --- | --- | --- | --- | --- | --- | --- | --- | --- | --- | --- | --- | --- |
| 23222175 | Clean and Modify Racks - 12GEV Shunts FY13 | 20d | 2013-09-03 | 2013-09-30 | 23222170 FS-44d, 23222170a FS-44d | 156d | 0d | 8/5 M-F w/JLAB Holidays ReBaseline | ELEC TECH [87.27 h] | 3,974.28 | 23222175 | MERZ B | 1 | 1 | U | BILL M | 10-028 | 12-028 | 12-029F | PE | EJ | 13-015 | PR |  |
| 23222180 | Reinstall Chassis' in Racks - 12GEV Shunts FY13 | 20d | 2013-09-03 | 2013-09-30 | 23222175a FS-44d, 23222175 FS-44d, 23222170a FS-44d, 23222170 FS-44d | 156d | 0d | 8/5 M-F w/JLAB Holidays ReBaseline | ELEC TECH [14.55 h] | 662.61 | 23222180 | MERZ B | 1 | 1 | U | BILL M | 10-028 | 12-028 | 12-029F | PE | EJ | 13-015 | PR |  |
| 23222185 | New Screens for 12 GEV Shunts FY13 | 20d | 2013-09-03 | 2013-09-30 | 9-130M FS+228d | 156d | 0d | 8/5 M-F w/JLAB Holidays ReBaseline | COMP SCIENT [18.18 h] | 1,230.97 | 23222185 | MERZ B | 1 | 1 | H | BILL M | 10-028 |  | 12-029F | PE | EJ | 13-015 | PR |  |
| 23222190 | Reconfiguration and Testing - 12GEV Shunts FY13 | 20d | 2013-09-03 | 2013-09-30 | 23222185 FS-44d, 23222180a FS-44d, 23222180 FS-44d, 23222185a FS-44d | 156d | 0d | 8/5 M-F w/JLAB Holidays ReBaseline | ELEC TECH [72.73 h] | 3,312.12 | 23222190 | MERZ B | 1 | 1 | U | BILL M | 10-028 | 12-028 | 12-029F | PE | EJ | 13-015 | PR |  |
| 23222195 | Update Machine Documentation - 12GEV Shunts FY13 | 20d | 2013-09-03 | 2013-09-30 | 23222190 FS-44d, 23222190a FS-44d | 156d | 0d | 8/5 M-F w/JLAB Holidays ReBaseline | ELEC DES [18.18 h]; ELEC ENG [9.09 h] | 1,609.38 | 23222195 | MERZ B | 1 | 1 | H | BILL M | 10-028 | 12-028 | 12-029F | PE | EJ | 13-015 | PR |  |
| 23222220 | Installation and Testing - 25 Amp Shunt Upgrade FY13 | 20d | 2013-09-03 | 2013-09-30 | 9-130M FS+228d | 156d | 0d | 8/5 M-F w/JLAB Holidays ReBaseline | ELEC TECH [18.18 h]; ELEC ENG [18.18 h] | 2,151.61 | 23222220 | MERZ B | 1 | 1 | U | BILL M | 10-028 | 12-028 | 12-029F | PE | EJ | 13-015 | PR |  |
| 23222230 | Drafting (Update Machine Drawings) FY13 | 20d | 2013-09-03 | 2013-09-30 | 23222220 FS-44d, 23222220a FS-44d | 156d | 0d | 8/5 M-F w/JLAB Holidays ReBaseline | ELEC DES [36.36 h]; ELEC ENG [3.64 h] | 2,160.03 | 23222230 | MERZ B | 1 | 1 | H | BILL M | 10-028 | 12-028 | 12-029F | PE | EJ | 13-015 | PR |  |
| 23222030a | Installation and Testing - Single Channel Shunt Chassis FY14 | 24d | 2013-10-01 | 2013-11-01 | 23222030, 9-130M FS+228d | 156d | 0d | 8/5 M-F w/JLAB Holidays ReBaseline | ELEC TECH [10.91 h] | 512.66 | 23222030 | MERZ B | 1 | 1 | U | BILL M | 10-028 | 12-028 | 12-029F | PE | EJ | 13-015 | PR | 14-001 |
| 23222035a | Data Entry / Paperwork - Single Channel Shunt Chassis FY14 | 24d | 2013-10-01 | 2013-11-01 | 23222030a FS-44d, 23222035, 23222030 FS-44d | 156d |  | 8/5 M-F w/JLAB Holidays ReBaseline | COMP SCIENT [1.09 h]; ELEC DES [1.09 h] | 134.78 | 23222035 | MERZ B | 1 | 1 | H | BILL M | 10-028 | 12-028 | 12-029F | PE | EJ | 13-015 | PR | 14-001 |
| 23222065 | Installation - Shunt Resistor Plates Part A FY14 | 42d | 2013-10-01 | 2013-11-27 | 9-130M FS+228d, 23222064 | 102d | 0d | 8/5 M-F w/JLAB Holidays ReBaseline | ELEC TECH [12 h] | 563.88 | 23222064 | MERZ B | 1 | 1 | U | BILL M | 10-028 | 12-028 |  | PE | EJ | 13-015 | PR | 14-001 |
| 23222068 | Update Machine Documentation - Shunt Resistor Plates Part A FY14 | 42d | 2013-10-01 | 2013-11-27 | 23222067, 23222064a FS-98d | 102d | 0d | 8/5 M-F w/JLAB Holidays ReBaseline | ELEC TECH [10.28 h] | 483.06 | 23222067 | MERZ B | 1 | 1 | H | BILL M | 10-028 | 12-028 |  | PE | EJ | 13-015 | PR | 14-001 |
| 23222070Ab | Engineering, Drafting and Software - Track Regulator and 30/80 Part A FY14 | 42d | 2013-10-01 | 2013-11-27 | 9-130M FS+228d, 23222070A | 101d | 0d | 8/5 M-F w/JLAB Holidays ReBaseline | COMP SCIENT [3.39 h]; ELEC ENG [10.18 h]; ELEC DES [6.79 h] | 1,366.9 | 23222070A | MERZ B | 1 | 1 | S | BILL M | 10-028 | 12-028 |  | EJ | EJ | 13-015 | PR | 14-001 |
| 23222075Ab | Oversight (Labor) - Track Regulator and 30/80 FY14 | 42d | 2013-10-01 | 2013-11-27 | 23222075A, 23222070Aa FS-99d | 101d | 0d | 8/5 M-F w/JLAB Holidays ReBaseline | ELEC ENG [16.97 h] | 1,274.96 | 23222075A | MERZ B | 1 | 1 | S | BILL M | 10-028 | 12-028 |  | EJ | EJ | 13-015 | PR | 14-001 |
| 23222080Ac | Procurement (Parts) - Track Regulator and 30/80 Part A Expenses FY14 | 42d | 2013-10-01 | 2013-11-27 | 23222080Ab, 23222075Aa FS-99d | 101d | 0d | 8/5 M-F w/JLAB Holidays ReBaseline | SUPPLIES & MATERIALS | 620.91 | 23222080A | MERZ B | 1 | 1 | D | BILL M | 10-028 | 12-028 |  | EJ | EJ | 13-015 | PR | 14-001 |
| 23222085Ab | Assembly and Testing - Track Regulator and 30/80 Part A FY14 | 42d | 2013-10-01 | 2013-11-27 | 23222080Aa FS-99d, 23222085A | 101d | 0d | 8/5 M-F w/JLAB Holidays ReBaseline | ELEC TECH [93.33 h] | 4,385.58 | 23222085A | MERZ B | 1 | 1 | S | BILL M | 10-028 | 12-028 |  | EJ | EJ | 13-015 | PR | 14-001 |
| 23222170a | Pull and Modify - 12GEV Shunt Shuffle FY14 | 24d | 2013-10-01 | 2013-11-01 | 9-130M FS+228d, 23222170 | 156d | 0d | 8/5 M-F w/JLAB Holidays ReBaseline | ELEC TECH [61.09 h] | 2,870.62 | 23222170 | MERZ B | 1 | 1 | U | BILL M | 10-028 | 12-028 | 12-029F | PE | EJ | 13-015 | PR | 14-001 |
| 23222175a | Clean and Modify Racks - 12GEV Shunts FY14 | 24d | 2013-10-01 | 2013-11-01 | 23222170 FS-44d, 23222175, 23222170a FS-44d | 156d | 0d | 8/5 M-F w/JLAB Holidays ReBaseline | ELEC TECH [104.72 h] | 4,920.79 | 23222175 | MERZ B | 1 | 1 | U | BILL M | 10-028 | 12-028 | 12-029F | PE | EJ | 13-015 | PR | 14-001 |
| 23222180a | Reinstall Chassis' in Racks - 12GEV Shunts FY14 | 24d | 2013-10-01 | 2013-11-01 | 23222180, 23222170 FS-44d, 23222170a FS-44d, 23222175 FS-44d, 23222175a FS-44d | 156d | 0d | 8/5 M-F w/JLAB Holidays ReBaseline | ELEC TECH [17.46 h] | 820.45 | 23222180 | MERZ B | 1 | 1 | U | BILL M | 10-028 | 12-028 | 12-029F | PE | EJ | 13-015 | PR | 14-001 |
| 23222185a | New Screens for 12 GEV Shunts FY14 | 24d | 2013-10-01 | 2013-11-01 | 9-130M FS+228d, 23222185 | 156d | 0d | 8/5 M-F w/JLAB Holidays ReBaseline | COMP SCIENT [21.82 h] | 1,524.56 | 23222185 | MERZ B | 1 | 1 | H | BILL M | 10-028 |  | 12-029F | PE | EJ | 13-015 | PR | 14-001 |
| 23222190a | Reconfiguration and Testing - 12GEV Shunts FY14 | 24d | 2013-10-01 | 2013-11-01 | 23222190, 23222185a FS-44d, 23222180 FS-44d, 23222180a FS-44d, 23222185 FS-44d | 156d | 0d | 8/5 M-F w/JLAB Holidays ReBaseline | ELEC TECH [87.28 h] | 4,101.29 | 23222190 | MERZ B | 1 | 1 | U | BILL M | 10-028 | 12-028 | 12-029F | PE | EJ | 13-015 | PR | 14-001 |
| 23222195a | Update Machine Documentation - 12GEV Shunts FY14 | 24d | 2013-10-01 | 2013-11-01 | 23222190 FS-44d, 23222195, 23222190a FS-44d | 156d |  | 8/5 M-F w/JLAB Holidays ReBaseline | ELEC DES [21.81 h]; ELEC ENG [10.91 h] | 1,992.54 | 23222195 | MERZ B | 1 | 1 | H | BILL M | 10-028 | 12-028 | 12-029F | PE | EJ | 13-015 | PR | 14-001 |
| 23222220a | Installation and Testing - 25 Amp Shunt Upgrade FY14 | 24d | 2013-10-01 | 2013-11-01 | 9-130M FS+228d, 23222220 | 156d | 0d | 8/5 M-F w/JLAB Holidays ReBaseline | ELEC TECH [21.82 h]; ELEC ENG [21.82 h] | 2,664.66 | 23222220 | MERZ B | 1 | 1 | U | BILL M | 10-028 | 12-028 | 12-029F | PE | EJ | 13-015 | PR | 14-001 |
| 23222230a | Drafting (Update Machine Drawings) FY14 | 24d | 2013-10-01 | 2013-11-01 | 23222230, 23222220a FS-44d, 23222220 FS-44d | 156d |  | 8/5 M-F w/JLAB Holidays ReBaseline | ELEC DES [43.64 h]; ELEC ENG [4.36 h] | 2,674.6 | 23222230 | MERZ B | 1 | 1 | H | BILL M | 10-028 | 12-028 | 12-029F | PE | EJ | 13-015 | PR | 14-001 |
| 23222064a | Installation - Shunt Resistor Plates Part B | 36d | 2013-12-02 | 2014-01-31 | 23222064, 23222065 | 102d | 0d | 8/5 M-F w/JLAB Holidays ReBaseline | ELEC TECH [8.75 h] | 411.16 | 23222064 | MERZ B | 1 | 1 | U | BILL M | 10-028 | 12-028 |  | PE | EJ | 13-015 | PR | 14-001 |
| 23222067a | Update Machine Documentation - Shunt Resistor Plates Part B | 36d | 2013-12-02 | 2014-01-31 | 23222067, 23222068 | 102d |  | 8/5 M-F w/JLAB Holidays ReBaseline | ELEC TECH [7.49 h] | 351.96 | 23222067 | MERZ B | 1 | 1 | H | BILL M | 10-028 | 12-028 |  | PE | EJ | 13-015 | PR | 14-001 |
| 23222070Aa | Engineering, Drafting and Software - Track Regulator and 30/80 Part B | 37d | 2013-12-02 | 2014-02-03 | 23222070A, 23222070Ab | 101d | 0d | 8/5 M-F w/JLAB Holidays ReBaseline | COMP SCIENT [2.54 h]; ELEC ENG [7.62 h]; ELEC DES [5.08 h] | 1,023.16 | 23222070A | MERZ B | 1 | 1 | S | BILL M | 10-028 | 12-028 |  | EJ | EJ | 13-015 | PR | 14-001 |
| 23222075Aa | Oversight (Labor) - Track Regulator and 30/80 | 37d | 2013-12-02 | 2014-02-03 | 23222075A, 23222075Ab | 101d | 0d | 8/5 M-F w/JLAB Holidays ReBaseline | ELEC ENG [12.7 h] | 954.15 | 23222075A | MERZ B | 1 | 1 | S | BILL M | 10-028 | 12-028 |  | EJ | EJ | 13-015 | PR | 14-001 |
| 23222080Aa | Procurement (Parts) - Track Regulator and 30/80 Part B | 37d | 2013-12-02 | 2014-02-03 | 23222080Ab, 23222080A, 23222080Ac | 101d | 0d | 8/5 M-F w/JLAB Holidays ReBaseline | SUPPLIES & MATERIALS | 464.95 | 23222080A | MERZ B | 1 | 1 | D | BILL M | 10-028 | 12-028 |  | EJ | EJ | 13-015 | PR | 14-001 |
| 23222085Aa | Assembly and Testing - Track Regulator and 30/80 Part A | 37d | 2013-12-02 | 2014-02-03 | 23222085Ab, 23222085A | 101d | 0d | 8/5 M-F w/JLAB Holidays ReBaseline | ELEC TECH [69.89 h] | 3,284.13 | 23222085A | MERZ B | 1 | 1 | S | BILL M | 10-028 | 12-028 |  | EJ | EJ | 13-015 | PR | 14-001 |
| 23222095 | Installation and Testing - Track Regulator and 30/80 | 37d | 2013-12-02 | 2014-02-03 | 23222085Aa FS-37d | 101d | 0d | 8/5 M-F w/JLAB Holidays ReBaseline | ELEC TECH [68 h]; ELEC ENG [68 h] | 8,304.16 | 23222095 | MERZ B | 1 | 1 | S | BILL M | 10-028 | 12-028 |  | EJ | EJ | 13-015 | PR | 14-001 |
| 23222100A | Data Entry/Paperwork - Track Regulator and 30/80 | 37d | 2013-12-02 | 2014-02-03 | 23222095 FS-37d | 101d | 0d | 8/5 M-F w/JLAB Holidays ReBaseline | ELEC DES [34 h]; ELEC TECH [34 h] | 3,426.18 | 23222100A | MERZ B | 1 | 1 | H | BILL M | 10-028 | 12-028 |  | EJ | EJ | 13-015 | PR | 14-001 |
| 23222142 | Update Machine Documentation - 75 Amp Shunt Upgrade | 37d | 2013-12-02 | 2014-02-03 | 23222100A FS-37d | 101d |  | 8/5 M-F w/JLAB Holidays ReBaseline | ELEC DES [6.8 h] | 365.7 | 23222142 | MERZ B | 1 | 1 | H | BILL M | 10-028 | 12-028 |  | PE | EJ | 13-015 | PR | 14-001 |

| ID | WBS | Activity | Type | Duration | Start | Finish | Predecessors | Total float | Free float | Calendar | Resources | Cost | RESP - Responsibility | STRT%COMP for CM EVM | FNSH%COMP for CM EVM | CR 08-005 | CAM RESPONSIBLE | CR 08-027 | CR 10-066 | CR 11-042 | CR 12-028 | Advance Purchase Plan > 500K | 12 GEV MAJOR PROCUREMENT CATAGORY | CR 10-028 | Milestone Level | CR 08-016 | CR 08-051 | CR 09-012 | CR 11-059 | CR 13-014 | ReBaseline Actuals Adjustment | Original Activity ID Rebaseline | EVMS Reporting Codes | BOE Labor | BOE Expenses | CR 13-015 | Post Rebaseline | Over Under Fixed | BOE Procurement | Obligated Prior to Rebaseline | Activities with Steps | CR 14-001 |
| --- | --- | --- | --- | --- | --- | --- | --- | --- | --- | --- | --- | --- | --- | --- | --- | --- | --- | --- | --- | --- | --- | --- | --- | --- | --- | --- | --- | --- | --- | --- | --- | --- | --- | --- | --- | --- | --- | --- | --- | --- | --- | --- |
|  | 3 | **1.3.2.2.3 TRIMS** |  |  | 2010-04-07 | 2014-02-03 |  |  |  |  |  |  |  |  |  |  |  |  |  |  |  |  |  |  |  |  |  |  |  |  |  |  |  |  |  |  |  |  |  |  |  |  |
| 13223038 |  | Bid 20 amp Trim PS (20 A Trims) |  | 120d | 2010-04-07 | 2010-09-24 | 9-100M FS+124d, 121223060a | 534d | 64d |  | ELEC ENG [100 h] | 6,627 | MERZ B | 1 | 1 | 08-005 | BILL M | 08-027 | 10-066 | 11-042 | 12-028F |  |  |  |  |  |  |  |  |  |  |  |  |  |  |  |  |  |  |  |  |  |
| 13223030 |  | Proc Rack Hardware for 20 amp Trim PS/Wait for Delivery (20 A TRIMS) |  | 80d | 2011-01-05 | 2011-04-28 | 121223060a, 9-110M FS+60d | 423d | 0d |  | PROCUREMENT<$50K 60; ELEC ENG [80 h] | 121,688.65 | MERZ B | 1 | 1 |  | BILL M |  |  | 11-042 | 12-028F | APP | 3223 | 10-028 |  |  |  |  |  |  |  |  |  |  |  |  |  |  |  |  |  |  |
| 13223039M |  | Award 20 amp Trim PS (20 A Trims) | milestone | 0d | 2011-01-05 | 2011-01-05 | 13223038, 9-110M FS+60d | 470d | 0d |  |  |  | MERZ B | 1 | 1 |  | BILL M | 08-027 | 10-066 | 11-042 | 12-028F |  |  |  | 6 |  |  |  |  |  |  |  |  |  |  |  |  |  |  |  |  |  |
| 13223045 |  | Monitor Design & Development &Test of First Article (20 A Trims) |  | 80d | 2011-01-05 | 2011-04-28 | 13223039M | 470d | 0d |  | ELEC ENG [80 h]; TRAVEL | 7,738.08 | MERZ B | 1 | 1 |  | BILL M |  | 10-066 | 11-042 | 12-028F |  |  |  |  |  |  |  |  |  |  |  |  |  |  |  |  |  |  |  |  |  |
| 13223035 |  | Assemble Racks for 20 amp Trim PS (20 A TRIMS) Frozen per CR12-028 |  | 108d | 2011-04-29 | 2011-09-30 | 13223030 | 474d | 337d |  | ELEC TECH [500 h]; SUPPLIES & MATERIALS | 25,920.34 | MERZ B | 1 | 1 |  | BILL M |  |  | 11-042 | 12-028F |  |  | 10-028 |  |  |  |  |  |  |  |  |  |  |  |  |  |  |  |  |  |  |
| 13223050 |  | Monitor Production and Delvery of PS (20 A Trims) P1(original Labor and Expenses) |  | 108d | 2011-04-29 | 2011-09-30 | 13223045 | 470d | 0d |  | ELEC ENG [20 h]; ELEC DES [30 h]; TRAVEL | 5,103.78 | MERZ B | 1 | 1 |  | BILL M | 08-027 | 10-066 | 11-042 | 12-028F | APP | 3223 | 10-028 |  | 08-016 | 08-051 | 09-012 |  |  |  |  |  |  |  |  |  |  |  |  |  |  |
| 13223051A |  | Vend Fab 20 Amp Trim Power Supplies - Peg Point #1 NRE |  | 47d | 2011-06-27 | 2011-08-31 | 9-110M FS+180d | 372d | 0d |  | PROCUREMENT<$50K 60 NO ESCALATION | 50,000 | MERZ B | 1 | 1 |  | BILL M | 08-027 | 10-066 | 11-042 | 12-028F | APP | 3223 | 10-028 |  | 08-016 | 08-051 | 09-012 |  |  |  |  |  |  |  |  |  |  |  |  |  |  |
| 13223051B |  | Vend Fab 20 Amp Trim Power Supplies - Peg Point #2 Approval of 1st Article Test |  | 89d | 2011-06-27 | 2011-10-31 | 13223051A FS-47d | 372d | 0d |  | PROCUREMENT>$50K 69 NO ESCALATION | 52,000 | MERZ B | 1 | 1 |  | BILL M | 08-027 | 10-066 | 11-042 | 12-028F | APP | 3223 | 10-028 |  | 08-016 | 08-051 | 09-012 |  |  |  |  |  |  |  |  |  |  |  |  |  |  |
| 13223051C |  | Vend Fab 20 Amp Trim Power Supplies - Peg Point #3 First Delivery and Acceptance of 30 units |  | 146d | 2011-06-27 | 2012-01-31 | 13223051B FS-89d | 372d | 0d |  | PROCUREMENT>$50K 69 NO ESCALATION | 150,000 | MERZ B | 1 | 1 |  | BILL M | 08-027 | 10-066 | 11-042 | 12-028F | APP | 3223 | 10-028 |  | 08-016 | 08-051 | 09-012 |  |  |  |  |  |  |  |  |  |  |  |  |  |  |
| 13223051D |  | Vend Fab 20 Amp Trim Power Supplies - Peg Point #4 Second Delivery and Acceptance of 30 units |  | 166d | 2011-06-27 | 2012-02-29 | 13223051C FS-146d | 372d | 0d |  | PROCUREMENT>$50K 69 NO ESCALATION | 150,000 | MERZ B | 1 | 1 |  | BILL M | 08-027 | 10-066 | 11-042 | 12-028F | APP | 3223 | 10-028 |  | 08-016 | 08-051 | 09-012 |  |  |  |  |  |  |  |  |  |  |  |  |  |  |
| 13223051 |  | Monitor Production and Delvery of PS (20 A Trims) P2 (original Labor and Expenses) |  | 150d | 2011-10-03 | 2012-05-11 | 9-120M, 13223045, 13223050 | 578d | 322d |  | TRAVEL; ELEC ENG [20 h]; ELEC DES [30 h] | 5,266.52 | MERZ B | 1 | 1 |  | BILL M | 08-027 | 10-066 | 11-042 | 12-028F | APP | 3223 | 10-028 |  | 08-016 | 08-051 | 09-012 |  |  |  |  |  |  |  |  |  |  |  |  |  |  |
| 13223052 |  | Receive , Inspect, Test PS (20 A Trims) P1 Frozen Per CR 12-028 |  | 91d | 2011-11-10 | 2012-03-29 | 13223050 FS-70d, 13223051D FS-70d | 384d | 128d |  | TRAVEL; ELEC TECH [120 h] | 7,635.62 | MERZ B | 1 | 1 |  | BILL M | 08-027 | 10-066 | 11-042 | 12-028F |  |  |  |  |  |  |  |  |  |  |  |  |  |  |  |  |  |  |  |  |  |
| 13223051F |  | Vend Fab 20 Amp Trim Power Supplies - Peg Point #5 Third Delivery and Acceptance of 30 units |  | 62d | 2012-01-03 | 2012-03-30 | 13223051D FS-40d | 381d | 0d |  | PROCUREMENT>$50K 69 NO ESCALATION; PROCUREMENT<$50K 60 NO ESCALATION | 120,000 | MERZ B | 1 | 1 |  | BILL M | 08-027 | 10-066 | 11-042 | 12-028F | APP | 3223 | 10-028 |  | 08-016 | 08-051 | 09-012 |  |  |  |  |  |  |  |  |  |  |  |  |  |  |
| 13223051G |  | Vend Fab 20 Amp Trim Power Supplies - Peg Point #6 Fourth Delivery and Acceptance of 30 units |  | 83d | 2012-01-03 | 2012-04-30 | 13223051F FS-62d | 381d | 0d |  | PROCUREMENT>$50K 69 NO ESCALATION | 120,000 | MERZ B | 1 | 1 |  | BILL M | 08-027 | 10-066 | 11-042 | 12-028F | APP | 3223 | 10-028 |  | 08-016 | 08-051 | 09-012 |  |  |  |  |  |  |  |  |  |  |  |  |  |  |
| 13223051H |  | Vend Fab 20 Amp Trim Power Supplies - Peg Point #7 Fifth Delivery and Acceptance of 30 units |  | 105d | 2012-01-03 | 2012-05-31 | 13223051G FS-83d | 381d | 0d |  | PROCUREMENT>$50K 69 NO ESCALATION | 120,000 | MERZ B | 1 | 1 |  | BILL M | 08-027 | 10-066 | 11-042 | 12-028F | APP | 3223 | 10-028 |  | 08-016 | 08-051 | 09-012 |  |  |  |  |  |  |  |  |  |  |  |  |  |  |
| 13223051J |  | Vend Fab 20 Amp Trim Power Supplies - Peg Point #8 Sixth Delivery and Acceptance of 30 units |  | 125d | 2012-01-03 | 2012-06-29 | 13223051H FS-105d | 381d | 0d |  | PROCUREMENT>$50K 69 NO ESCALATION | 120,000 | MERZ B | 1 | 1 |  | BILL M | 08-027 | 10-066 | 11-042 | 12-028F | APP | 3223 | 10-028 |  | 08-016 | 08-051 | 09-012 |  |  |  |  |  |  |  |  |  |  |  |  |  |  |
| 13223051K |  | Vend Fab 20 Amp Trim Power Supplies - Peg Point #9 Seventh Delivery and Acceptance of 30 units |  | 147d | 2012-01-03 | 2012-07-31 | 13223051J FS-125d | 381d | 0d |  | PROCUREMENT>$50K 69 NO ESCALATION | 120,000 | MERZ B | 1 | 1 |  | BILL M | 08-027 | 10-066 | 11-042 | 12-028F | APP | 3223 | 10-028 |  | 08-016 | 08-051 | 09-012 |  |  |  |  |  |  |  |  |  |  |  |  |  |  |
| 13223051N |  | Vend Fab 20 Amp Trim Power Supplies - Peg Point #10 Eighth Delivery and Acceptance of 30 units |  | 170d | 2012-01-03 | 2012-08-31 | 13223051K FS-147d | 381d | 0d |  | PROCUREMENT>$50K 69 NO ESCALATION | 120,000 | MERZ B | 1 | 1 |  | BILL M | 08-027 | 10-066 | 11-042 | 12-028F | APP | 3223 | 10-028 |  | 08-016 | 08-051 | 09-012 |  |  |  |  |  |  |  |  |  |  |  |  |  |  |
| 13223051P |  | Vend Fab 20 Amp Trim Power Supplies - Peg Point #11 Final Delivery and Acceptance of 20 units |  | 189d | 2012-01-03 | 2012-09-28 | 13223051N FS-170d | 381d | 0d |  | PROCUREMENT>$50K 69 NO ESCALATION | 80,000 | MERZ B | 1 | 1 |  | BILL M | 08-027 | 10-066 | 11-042 | 12-028F | APP | 3223 | 10-028 |  | 08-016 | 08-051 | 09-012 |  |  |  |  |  |  |  |  |  |  |  |  |  |  |
| 13223051Q |  | ** Option** Vend Fab 20 Amp Trim Power Supplies - Peg Point #12 Delivery and Acceptance of 10 units |  | 189d | 2012-01-03 | 2012-09-28 | 13223051P FS-189d | 381d | 125d |  | PROCUREMENT>$50K 69 NO ESCALATION | 40,000 | MERZ B | 1 | 1 |  | BILL M | 08-027 | 10-066 | 11-042 | 12-028F | APP | 3223 | 10-028 |  | 08-016 | 08-051 | 09-012 |  |  |  |  |  |  |  |  |  |  |  |  |  |  |
| 13223035A |  | Reverse Entry Per CR12-028 |  | 15d | 2012-03-05 | 2012-03-23 | 9-120M FS+100d | 132d |  |  | ELEC TECH [-604.4 h]; SUPPLIES & MATERIALS; TRAVEL | -33,555.96 | MERZ B | 1 | 1 |  | BILL M |  |  | 11-042 | 12-028 |  |  | 10-028 |  |  |  |  |  |  |  |  |  |  |  |  |  |  |  |  |  |  |
| 13223036 |  | Assemble Racks for 20 amp Trims Part A |  | 69d | 2012-04-02 | 2012-07-09 | 9-120M FS+120d, 13223030 | 195d | 58d |  | ELEC TECH [120 h]; SUPPLIES & MATERIALS | 6,795.6 | MERZ B | 1 | 1 |  | BILL M |  |  | 11-042 | 12-028 |  |  | 10-028 |  |  |  |  |  |  |  |  |  |  |  |  |  |  |  |  |  |  |
| 13223052A |  | Receive , Inspect, Test PS (20 A Trims) P1 Revised Per CR 12-028 |  | 103d | 2012-05-04 | 2012-09-28 | 9-120M FS+144d, 13223050 FS-70d, 13223051D FS-70d | 256d | 0d |  | ELEC TECH [160 h]; ELEC ENG [40 h]; TRAVEL | 12,223.22 | MERZ B | 1 | 1 |  | BILL M | 08-027 | 10-066 | 11-042 | 12-028 |  |  |  |  |  |  |  |  |  |  |  |  |  |  |  |  |  |  |  |  |  |
| 13223010 |  | Relocate and Reuse Trim Hardware for Hall D |  | 60d | 2012-05-14 | 2012-08-07 | 2-02M | 359d | 37d |  | ELEC TECH [120 h]; SUPPLIES & MATERIALS; ELEC ENG [20 h]; SKLLD TRADE [40 h] | 13,368.89 | MERZ B | 1 | 1 |  | BILL M |  |  |  | 12-028 |  |  | 10-028 |  |  |  |  |  |  |  |  |  |  |  |  |  |  |  |  |  |  |
| 13223110 |  | SRCC 20 Amp PS PS Procurement |  | 86d | 2012-07-03 | 2012-10-31 | 9-120M FS+184d | 132d | 57d |  | PROCUREMENT<$50K 60 NO ESCALATION FY13 | 20,000 | MERZ B | 1 | 1 |  | BILL M | 08-027 | 10-066 | 11-042 | 12-028 |  |  |  |  |  |  |  | 11-059 |  |  |  |  |  |  |  |  |  |  |  |  |  |
| 13223055 |  | Install PS in Racks (20 A Trims) Part A |  | 62d | 2012-07-04 | 2012-09-28 | 13223052A FS-225d, 13223053 FS-125d, 13223052 FS-225d | 256d | 0d |  | ELEC TECH [252 h] | 11,120.76 | MERZ B | 1 | 1 |  | BILL M | 08-027 | 10-066 | 11-042 | 12-028 |  |  |  |  |  |  |  |  |  |  |  |  |  |  |  |  |  |  |  |  |  |
| 13223015 |  | Test Trim Rack Hardware (10 ATRIMS) |  | 43d | 2012-10-01 | 2012-11-30 | 13223010, 9-130M | 322d | 287d |  | ELEC TECH [40 h]; ELEC ENG [20 h] | 3,277.8 | MERZ B | 1 | 1 |  | BILL M |  |  |  | 12-028 |  |  | 10-028 |  |  |  |  |  |  |  |  |  |  |  |  |  |  |  |  |  |  |
| 13223020 |  | Reconfigure 10 Amp Trim System (Arc 10 Hall D) (10 A TRIMS) |  | 143d | 2012-10-01 | 2013-05-01 | 3A-22M, 9-130M | 158d | 0d |  | ELEC ENG [20 h]; ELEC TECH [240 h]; COMP SCIENT [80 h] | 17,802.6 | MERZ B | 1 | 1 |  | BILL M |  |  |  | 12-028 |  |  | 10-028 |  |  |  |  |  |  |  |  |  |  |  |  |  |  |  |  |  |  |
| 13223036A |  | Assemble Racks for 20 amp Trims Part B |  | 90d | 2012-10-01 | 2013-02-14 | 9-130M, 13223036 | 137d | 0d |  | ELEC TECH [480 h]; SUPPLIES & MATERIALS | 24,991.02 | MERZ B | 1 | 1 |  | BILL M |  |  | 11-042 | 12-028 |  |  | 10-028 |  |  |  |  |  |  |  |  |  |  |  |  |  |  |  |  |  |  |
| 13223053 |  | Receive , Inspect, Test PS (20 A Trims) P2 |  | 63d | 2012-10-01 | 2013-01-07 | 13223052, 13223051Q FS-125d, 13223052A, 13223051 FS-225d | 256d | 0d |  | TRAVEL; ELEC TECH [120 h] | 7,879.47 | MERZ B | 1 | 1 |  | BILL M | 08-027 | 10-066 | 11-042 | 12-028 |  |  |  |  |  |  |  |  |  |  |  |  |  |  |  |  |  |  |  |  |  |
| 13223055A |  | Install PS in Racks (20 A Trims) Part B |  | 101d | 2012-10-01 | 2013-03-04 | 13223055 | 256d | 119d |  | ELEC TECH [240 h] | 10,929.6 | MERZ B | 1 | 1 |  | BILL M | 08-027 | 10-066 | 11-042 | 12-028 |  |  |  |  |  |  |  |  |  |  |  |  |  |  |  |  |  |  |  |  |  |
| 13223100 |  | SRCC Engineering Design, Planning and Oversight |  | 43d | 2012-10-01 | 2012-11-30 | 9-130M | 75d | 0d |  | ELEC ENG [120 h] | 8,737.2 | MERZ B | 1 | 1 |  | BILL M | 08-027 | 10-066 | 11-042 | 12-028 |  |  |  |  |  |  |  | 11-059 |  |  |  |  |  |  |  |  |  |  |  |  |  |
| 13223112 |  | SRCC Cable & Misc Procurement |  | 80d | 2012-10-01 | 2013-01-31 | 13223100 FS-43d, 13223105 FS-59d | 75d | 0d |  | PROCUREMENT<$50K 60 | 10,319 | MERZ B | 1 | 1 |  | BILL M | 08-027 | 10-066 | 11-042 | 12-028 |  |  |  |  |  |  |  | 11-059 |  |  |  |  |  |  |  |  |  |  |  |  |  |
| 13223105 |  | SRCC Drafting |  | 16d | 2012-12-03 | 2012-12-31 | 13223100 | 75d | 0d |  | ELEC ENG [80 h] | 5,824.8 | MERZ B | 1 | 1 |  | BILL M | 08-027 | 10-066 | 11-042 | 12-028 |  |  |  |  |  |  |  | 11-059 |  |  |  |  |  |  |  |  |  |  |  |  |  |
| 13223115 |  | SRCC PS and Rack installation |  | 20d | 2013-02-01 | 2013-03-01 | 13223112, 13223110 | 75d | 0d |  | ELEC TECH [80 h]; SKLLD TRADE [40 h] | 5,024 | MERZ B | 1 | 1 |  | BILL M | 08-027 | 10-066 | 11-042 | 12-028 |  |  |  |  |  |  |  | 11-059 |  |  |  |  |  |  |  |  |  |  |  |  |  |
| 13223060 |  | Integration Testing of PS (20 A Trims) |  | 138d | 2013-02-15 | 2013-08-30 | 13223036, 13223055 FS-130d, 13223036A, 13223055A FS-130d, 2-02M, 13223035 | 137d | 102d |  | ELEC TECH [197.15 h]; COMP SCIENT [118.29 h]; SUPPLIES & MATERIALS; ELEC ENG [23.66 h] | 22,279.97 | MERZ B | 1 | 1 |  | BILL M | 08-027 | 10-066 | 11-042 | 12-028 |  |  |  |  |  |  |  |  |  |  |  |  |  |  |  |  |  |  |  |  |  |
| 13223120 |  | SRCC Cable Installation, Termination and Hook-up |  | 42d | 2013-03-04 | 2013-04-30 | 13223112, 13223115, 13223110 | 75d | 0d |  | ELEC TECH [160 h] | 7,286.4 | MERZ B | 1 | 1 |  | BILL M | 08-027 | 10-066 | 11-042 | 12-028 |  |  |  |  |  |  |  | 11-059 |  |  |  |  |  |  |  |  |  |  |  |  |  |
| 13223125 |  | SRCC System Q.A., Testing and Documentation |  | 20d | 2013-05-01 | 2013-05-29 | 13223120, 13223115 | 75d |  |  | ELEC TECH [80 h]; COMP SCIENT [40 h]; ELEC ENG [40 h] | 9,264 | MERZ B | 1 | 1 |  | BILL M | 08-027 | 10-066 | 11-042 | 12-028 |  |  |  |  |  |  |  | 11-059 |  |  |  |  |  |  |  |  |  |  |  |  |  |
| 13223025 |  | Assemble & Test 10 amp Trim System (10 A TRIMS) |  | 64d | 2013-05-02 | 2013-08-01 | 13223020 | 158d | 123d |  | ELEC TECH [160 h]; ELEC ENG [40 h]; COMP SCIENT [40 h] | 12,907.2 | MERZ B | 1 | 1 |  | BILL M |  |  |  | 12-028 |  |  | 10-028 |  |  |  |  |  |  |  |  |  |  |  |  |  |  |  |  |  |  |
| 13223130 |  | Re-Baseline Actuals Adjustment |  | 1d | 2013-08-30 | 2013-08-30 | 9-130M FS+227d | 20d |  |  | PROCUREMENT>$50K 69 NO ESCALATION | -235,014.13 | MERZ B | 1 | 1 |  | BILL M |  |  |  |  |  |  |  |  |  |  |  |  | 13-014 | ADJ |  |  |  |  |  |  |  |  |  |  |  |
| 23223015 |  | Test Trim Rack Hardware (10 ATRIMS) FY13 |  | 20d | 2013-09-03 | 2013-09-30 | 9-130M FS+228d | 97d | 0d | 8/5 M-F w/JLAB Holidays ReBaseline | ELEC TECH [18.46 h]; ELEC ENG [9.23 h] | 1,512.71 | MERZ B | 1 | 1 |  | BILL M |  |  |  | 12-028 |  |  | 10-028 |  |  |  |  |  |  |  | 23223015 | U | EJ | EJ | 13-015 | PR |  |  |  |  |  |
| 23223025 |  | Assemble & Test 10 amp Trim System (10 A TRIMS) FY13 |  | 20d | 2013-09-03 | 2013-09-30 | 9-130M FS+228d | 97d | 0d | 8/5 M-F w/JLAB Holidays ReBaseline | ELEC TECH [82.05 h]; ELEC ENG [20.51 h]; COMP SCIENT [20.51 h] | 6,619.25 | MERZ B | 1 | 1 |  | BILL M |  |  |  | 12-028 |  |  | 10-028 |  |  |  |  |  |  |  | 23223025 | U | EJ | EJ | 13-015 | PR |  |  |  |  |  |
| 23223051H |  | Vend Fab 20 Amp Trim Power Supplies - Peg Point #7 Fifth Delivery and Acceptance of 30 units |  | 20d | 2013-09-03 | 2013-09-30 | 9-130M FS+228d | 53d | 0d | 8/5 M-F w/JLAB Holidays ReBaseline | PROCUREMENT<$50K 60 NO ESCALATION; PROCUREMENT>$50K 69 NO ESCALATION | 77,161.74 | MERZ B | 1 | 1 |  | BILL M | 08-027 | 10-066 | 11-042 | 12-028F | APP | 3223 | 10-028 |  | 08-016 | 08-051 | 09-012 |  |  |  | 23223051H | D |  |  | 13-015 | PR | y | OB | OB |  |  |
| 23223051J |  | Vend Fab 20 Amp Trim Power Supplies - Peg Point #8 Sixth Delivery and Acceptance of 30 units |  | 43d | 2013-09-03 | 2013-10-31 | 23223051H FS-20d | 53d | 0d | 8/5 M-F w/JLAB Holidays ReBaseline | PROCUREMENT>$50K 69 NO ESCALATION | 77,161.74 | MERZ B | 1 | 1 |  | BILL M | 08-027 | 10-066 | 11-042 | 12-028F | APP | 3223 | 10-028 |  | 08-016 | 08-051 | 09-012 |  |  |  | 23223051J | D |  |  | 13-015 | PR | y | OB | OB |  |  |
| 23223051K |  | Vend Fab 20 Amp Trim Power Supplies - Peg Point #9 Seventh Delivery and Acceptance of 30 units |  | 62d | 2013-09-03 | 2013-11-27 | 23223051J FS-43d | 53d | 0d | 8/5 M-F w/JLAB Holidays ReBaseline | PROCUREMENT>$50K 69 NO ESCALATION | 77,161.74 | MERZ B | 1 | 1 |  | BILL M | 08-027 | 10-066 | 11-042 | 12-028F | APP | 3223 | 10-028 |  | 08-016 | 08-051 | 09-012 |  |  |  | 23223051K | D |  |  | 13-015 | PR | y | OB | OB |  |  |
| 23223051N |  | Vend Fab 20 Amp Trim Power Supplies - Peg Point #10 Eighth Delivery and Acceptance of 30 units |  | 62d | 2013-09-03 | 2013-11-27 | 23223051K FS-62d | 53d | 0d | 8/5 M-F w/JLAB Holidays ReBaseline | PROCUREMENT>$50K 69 NO ESCALATION | 77,161.74 | MERZ B | 1 | 1 |  | BILL M | 08-027 | 10-066 | 11-042 | 12-028F | APP | 3223 | 10-028 |  | 08-016 | 08-051 | 09-012 |  |  |  | 23223051N | D |  |  | 13-015 | PR | y | OB | OB |  |  |
| 23223051P |  | Vend Fab 20 Amp Trim Power Supplies - Peg Point #11 Final Delivery and Acceptance of 20 units |  | 77d | 2013-09-03 | 2013-12-20 | 23223051N FS-62d | 53d | 0d | 8/5 M-F w/JLAB Holidays ReBaseline | PROCUREMENT>$50K 69 NO ESCALATION | 51,441.16 | MERZ B | 1 | 1 |  | BILL M | 08-027 | 10-066 | 11-042 | 12-028F | APP | 3223 | 10-028 |  | 08-016 | 08-051 | 09-012 |  |  |  | 23223051P | D |  |  | 13-015 | PR | y | OB | OB |  |  |
| 23223051Q |  | ** Option** Vend Fab 20 Amp Trim Power Supplies - Peg Point #12 Delivery and Acceptance of 10 units |  | 98d | 2013-09-03 | 2014-01-31 | 23223051P FS-77d | 53d | 17d | 8/5 M-F w/JLAB Holidays ReBaseline | PROCUREMENT>$50K 69 NO ESCALATION | 30,776 | MERZ B | 1 | 1 |  | BILL M | 08-027 | 10-066 | 11-042 | 12-028F | APP | 3223 | 10-028 |  | 08-016 | 08-051 | 09-012 |  |  |  | 23223051Q | D |  |  | 13-015 | PR | y | OB | OB |  |  |
| 23223052A |  | Receive , Inspect, Test PS (20 A Trims) P1 FY13 |  | 20d | 2013-09-03 | 2013-09-30 | 9-130M FS+228d | 37d | 0d | 8/5 M-F w/JLAB Holidays ReBaseline | ELEC TECH [9.32 h]; ELEC ENG [2.33 h]; TRAVEL | 730.41 | MERZ B | 1 | 1 |  | BILL M | 08-027 | 10-066 | 11-042 | 12-028 |  |  |  |  |  |  |  |  |  |  | 23223052A | U | EJ | EJ | 13-015 | PR |  |  |  |  |  |
| 23223053 |  | Receive , Inspect, Test PS (20 A Trims) P2 Procurement |  | 62d | 2013-09-03 | 2013-11-27 | 23223052A FS-21d, 23223052Aa FS-21d | 52d | 0d | 8/5 M-F w/JLAB Holidays ReBaseline | TRAVEL; ELEC TECH; PROCUREMENT<$50K 60 NO ESCALATION FY14 | 1,155.03 | MERZ B | 1 | 1 |  | BILL M | 08-027 | 10-066 | 11-042 | 12-028 |  |  |  |  |  |  |  |  |  |  | 23223053 | U | EJ | EJ | 13-015 | PR | y |  | OB |  |  |
| 23223054 |  | Receive , Inspect, Test PS (20 A Trims) P2 Labor/Expenses FY13 |  | 20d | 2013-09-03 | 2013-09-30 | 23223052A FS-21d, 23223052Aa FS-21d | 52d | 0d | 8/5 M-F w/JLAB Holidays ReBaseline | TRAVEL; ELEC TECH [27.91 h] | 1,832.57 | MERZ B | 1 | 1 |  | BILL M | 08-027 | 10-066 | 11-042 | 12-028 |  |  |  |  |  |  |  |  |  |  | 23223053 | U | EJ | EJ | 13-015 | PR |  |  |  |  |  |
| 23223055 |  | Install PS in Racks (20 A Trims) Part A FY13 |  | 20d | 2013-09-03 | 2013-09-30 | 23223052A FS-21d, 23223052Aa FS-21d, 23223053a FS-101d | 37d | 0d | 8/5 M-F w/JLAB Holidays ReBaseline | ELEC TECH [40.65 h] | 1,851.2 | MERZ B | 1 | 1 |  | BILL M | 08-027 | 10-066 | 11-042 | 12-028 |  |  |  |  |  |  |  |  |  |  | 23223055 | U | EJ | EJ | 13-015 | PR |  |  |  |  |  |
| 23223110 |  | SRCC 20 Amp PS PS Procurement |  | 67d | 2013-09-03 | 2013-12-06 | 9-130M FS+228d | 42d | 0d | 8/5 M-F w/JLAB Holidays ReBaseline | PROCUREMENT>$50K 69 NO ESCALATION | 15,380.25 | MERZ B | 1 | 1 |  | BILL M | 08-027 | 10-066 | 11-042 | 12-028 |  |  |  |  |  |  |  | 11-059 |  |  | 23223110 | D |  |  | 13-015 | PR | y | OB | OB |  |  |
| 23223125 |  | SRCC System Q.A., Testing and Documentation Part A FY13 |  | 20d | 2013-09-03 | 2013-09-30 | 23223110 FS-67d | 42d | 0d | 8/5 M-F w/JLAB Holidays ReBaseline | ELEC TECH [23.88 h]; COMP SCIENT [11.94 h]; ELEC ENG [11.94 h] | 2,765.31 | MERZ B | 1 | 1 |  | BILL M | 08-027 | 10-066 | 11-042 | 12-028 |  |  |  |  |  |  |  | 11-059 |  |  | 23223125 | S | PE | EJ | 13-015 | PR |  |  |  | ST |  |
| 23223015a |  | Test Trim Rack Hardware (10 ATRIMS) FY14 |  | 19d | 2013-10-01 | 2013-10-25 | 9-130M FS+228d, 23223015 | 97d | 61d | 8/5 M-F w/JLAB Holidays ReBaseline | ELEC TECH [17.54 h]; ELEC ENG [8.77 h] | 1,483.09 | MERZ B | 1 | 1 |  | BILL M |  |  |  | 12-028 |  |  | 10-028 |  |  |  |  |  |  |  | 23223015 | U | EJ | EJ | 13-015 | PR |  |  |  |  | 14-001 |
| 23223025a |  | Assemble & Test 10 amp Trim System (10 A TRIMS) FY14 |  | 19d | 2013-10-01 | 2013-10-25 | 23223025, 9-130M FS+228d | 97d | 61d | 8/5 M-F w/JLAB Holidays ReBaseline | ELEC TECH [77.95 h]; ELEC ENG [19.49 h]; COMP SCIENT [19.49 h] | 6,488.27 | MERZ B | 1 | 1 |  | BILL M |  |  |  | 12-028 |  |  | 10-028 |  |  |  |  |  |  |  | 23223025 | U | EJ | EJ | 13-015 | PR |  |  |  |  | 14-001 |
| 23223052Aa |  | Receive , Inspect, Test PS (20 A Trims) P1 FY14 |  | 1d | 2013-10-01 | 2013-10-01 | 23223052A, 9-130M FS+228d | 37d | 0d | 8/5 M-F w/JLAB Holidays ReBaseline | ELEC TECH [0.46 h]; ELEC ENG [0.12 h]; TRAVEL | 37.56 | MERZ B | 1 | 1 |  | BILL M | 08-027 | 10-066 | 11-042 | 12-028 |  |  |  |  |  |  |  |  |  |  | 23223052A | U | EJ | EJ | 13-015 | PR |  |  |  |  | 14-001 |
| 23223054a |  | Receive , Inspect, Test PS (20 A Trims) P2 Labor/Expenses FY14 |  | 42d | 2013-10-01 | 2013-11-27 | 23223052A FS-21d, 23223054, 23223052Aa FS-21d | 52d | 0d | 8/5 M-F w/JLAB Holidays ReBaseline | TRAVEL; ELEC TECH [58.6 h] | 3,970.48 | MERZ B | 1 | 1 |  | BILL M | 08-027 | 10-066 | 11-042 | 12-028 |  |  |  |  |  |  |  |  |  |  | 23223053 | U | EJ | EJ | 13-015 | PR |  |  |  |  | 14-001 |
| 23223055b |  | Install PS in Racks (20 A Trims) Part A FY14 |  | 11d | 2013-10-01 | 2013-10-15 | 23223052A FS-21d, 23223053a FS-101d, 23223055, 23223052Aa FS-21d | 37d | 0d | 8/5 M-F w/JLAB Holidays ReBaseline | ELEC TECH [22.35 h] | 1,050.23 | MERZ B | 1 | 1 |  | BILL M | 08-027 | 10-066 | 11-042 | 12-028 |  |  |  |  |  |  |  |  |  |  | 23223055 | U | EJ | EJ | 13-015 | PR |  |  |  |  | 14-001 |
| 23223125b |  | SRCC System Q.A., Testing and Documentation Part A FY14 |  | 42d | 2013-10-01 | 2013-11-27 | 23223110 FS-67d, 23223125 | 42d | 0d | 8/5 M-F w/JLAB Holidays ReBaseline | ELEC TECH [50.15 h]; COMP SCIENT [25.07 h]; ELEC ENG [25.07 h] | 5,992.42 | MERZ B | 1 | 1 |  | BILL M | 08-027 | 10-066 | 11-042 | 12-028 |  |  |  |  |  |  |  | 11-059 |  |  | 23223125 | S | PE | EJ | 13-015 | PR |  |  |  | ST | 14-001 |
| 23223060 |  | Integration Testing of PS (20 A Trims) Part A |  | 62d | 2013-10-02 | 2014-01-09 | 23223055A FS-130d, 23223055b FS-10d, 23223055 FS-10d | 37d | 0d | 8/5 M-F w/JLAB Holidays ReBaseline | ELEC TECH [98.37 h]; COMP SCIENT [59.02 h]; SUPPLIES & MATERIALS; ELEC ENG [11.81 h] | 11,471.71 | MERZ B | 1 | 1 |  | BILL M | 08-027 | 10-066 | 11-042 | 12-028 |  |  |  |  |  |  |  |  |  |  | 23223060 | U | EJ | EJ | 13-015 | PR |  |  |  |  | 14-001 |
| 23223055A |  | Install PS in Racks (20 A Trims) Part B |  | 36d | 2013-11-20 | 2014-01-23 | 23223055 FS-30d, 23223053a FS-30d, 23223055b FS-30d | 96d | 59d | 8/5 M-F w/JLAB Holidays ReBaseline | ELEC TECH [204 h] | 9,585.96 | MERZ B | 1 | 1 |  | BILL M | 08-027 | 10-066 | 11-042 | 12-028 |  |  |  |  |  |  |  |  |  |  | 23223055A | U | EJ | EJ | 13-015 | PR |  |  |  |  | 14-001 |
| 23223053a |  | Receive , Inspect, Test PS (20 A Trims) P3 |  | 24d | 2013-12-02 | 2014-01-14 | 23223053, 23223054a, 23223054 | 52d | 0d | 8/5 M-F w/JLAB Holidays ReBaseline | TRAVEL; ELEC TECH [20.52 h] | 1,555.28 | MERZ B | 1 | 1 |  | BILL M | 08-027 | 10-066 | 11-042 | 12-028 |  |  |  |  |  |  |  |  |  |  | 23223053 | U | EJ | EJ | 13-015 | PR |  |  |  |  | 14-001 |
| 23223125a |  | SRCC System Q.A., Testing and Documentation Part B |  | 5d | 2013-12-02 | 2013-12-06 | 23223125, 23223125b, 23223110 FS-67d | 42d |  | 8/5 M-F w/JLAB Holidays ReBaseline | ELEC TECH [5.08 h]; COMP SCIENT [2.54 h]; ELEC ENG [2.54 h] | 606.41 | MERZ B | 1 | 1 |  | BILL M | 08-027 | 10-066 | 11-042 | 12-028 |  |  |  |  |  |  |  | 11-059 |  |  | 23223125 | S | PE | EJ | 13-015 | PR |  |  |  | ST | 14-001 |
| 23223060a |  | Integration Testing of PS (20 A Trims) Part B |  | 16d | 2014-01-10 | 2014-02-03 | 23223060 | 37d | 1d | 8/5 M-F w/JLAB Holidays ReBaseline | ELEC TECH [75.46 h]; COMP SCIENT [45.28 h]; SUPPLIES & MATERIALS; ELEC ENG [9.06 h] | 8,799.71 | MERZ B | 1 | 1 |  | BILL M | 08-027 | 10-066 | 11-042 | 12-028 |  |  |  |  |  |  |  |  |  |  | 23223060 | U | EJ | EJ | 13-015 | PR |  |  |  |  | 14-001 |

Notes:
- 23223125: Steps: Arc 7 Complete; Arc 8 Complete; Arc 9 Complete; Arc 10 Complete; Documentation Complete
- 23223125b: Steps: Arc 7 Complete; Arc 8 Complete; Arc 9 Complete; Arc 10 Complete; Documentation Complete
- 23223125a: Steps: Arc 7 Complete; Arc 8 Complete; Arc 9 Complete; Arc 10 Complete; Documentation Complete

| ID | WBS | Activity | Duration | Start | Finish | Predecessors | Total float | Free float | Calendar | Resources | Cost | RESP - Responsibility | STRT%COMP for CM EVM | FNSH%COMP for CM EVM | CAM RESPONSIBLE | CR 10-028 | CR 12-028 | CR 08-041 | CR 08-051 | CR 11-055 | CR 12-029 | CR 12-050 | CR 12-001 | CR 12-035 | CR 10-059 | CR 11-044 | CR 12-053 | CR 13-014 | CR 10-065 | ReBaseline Actuals Adjustment | Original Activity ID Rebaseline | EVMS Reporting Codes | BOE Labor | BOE Expenses | CR 13-015 | Post Rebaseline | BOE NOTES | Over Under Fixed | BOE Adder | Obligated Prior to Rebaseline | Activities with Steps | CR 14-001 |
| --- | --- | --- | --- | --- | --- | --- | --- | --- | --- | --- | --- | --- | --- | --- | --- | --- | --- | --- | --- | --- | --- | --- | --- | --- | --- | --- | --- | --- | --- | --- | --- | --- | --- | --- | --- | --- | --- | --- | --- | --- | --- | --- |
|  | 4 | **1.3.2.2.4 INSTALLATION** |  | 2010-06-11 | 2013-11-06 |  |  |  |  |  |  |  |  |  |  |  |  |  |  |  |  |  |  |  |  |  |  |  |  |  |  |  |  |  |  |  |  |  |  |  |  |  |
| 13224000LOE |  | Installation Coordination FY10 | 78d | 2010-06-11 | 2010-09-30 | 9-100M FS+170d | 237d | 0d |  | ELEC DES [320 h] | 15,180.8 | MERZ B | 1 | 1 | BILL M | 10-028 | 12-028F |  |  |  |  |  |  |  |  |  |  |  |  |  |  |  |  |  |  |  |  |  |  |  |  |  |
| 13224001LOE |  | Installation Coordination FY11 | 248d | 2010-10-01 | 2011-09-30 | 13224000LOE | 237d | 0d |  | ELEC DES [457.85 h] | 22,411.76 | MERZ B | 1 | 1 | BILL M | 10-028 | 12-028F |  |  |  |  |  |  |  |  |  |  |  |  |  |  |  |  |  |  |  |  |  |  |  |  |  |
| 13224005 |  | Proc Box PS Load Cable/Hardware (Installtn) | 60d | 2010-10-01 | 2011-01-04 | 9-110M, 121224999 | 434d | 110d |  | PROCUREMENT<$50K 60; ELEC DES [40 h] | 108,538.64 | MERZ B | 1 | 1 | BILL M | 10-028 |  |  |  |  |  |  |  |  |  |  |  |  |  |  |  |  |  |  |  |  |  |  |  |  |  |  |
| 13224010 |  | Proc Trim Mag & Shunt Cable (Installtn) | 60d | 2010-10-01 | 2011-01-04 | 121224999, 9-110M | 434d | 110d |  | PROCUREMENT<$50K 60; ELEC DES [40 h] | 52,692.95 | MERZ B | 1 | 1 | BILL M | 10-028 |  | 08-041 | 08-051 |  |  |  |  |  |  |  |  |  |  |  |  |  |  |  |  |  |  |  |  |  |  |  |
| 13224015 |  | Proc Trim Sys AC Pwr, Controls & Interlock Cable (Installtn) | 60d | 2010-10-01 | 2011-01-04 | 9-110M, 121224999 | 434d | 110d |  | PROCUREMENT<$50K 60; ELEC DES [40 h] | 54,602.03 | MERZ B | 1 | 1 | BILL M | 10-028 |  |  |  |  |  |  |  |  |  |  |  |  |  |  |  |  |  |  |  |  |  |  |  |  |  |  |
| 13224020 |  | Proc Box PS Cable Tray, AC Pwr Matrl's (Installtn) | 60d | 2010-10-01 | 2011-01-04 | 121224999, 9-110M | 434d | 110d |  | PROCUREMENT<$50K 60; ELEC DES [40 h] | 71,915.72 | MERZ B | 1 | 1 | BILL M | 10-028 |  |  |  |  |  |  |  |  |  |  |  |  |  |  |  |  |  |  |  |  |  |  |  |  |  |  |
| 13224025 |  | Proc DC Pwr Interconnect Hardware (Installtn) | 60d | 2010-10-01 | 2011-01-04 | 9-110M, 121224999 | 434d | 110d |  | PROCUREMENT<$50K 60; ELEC DES [40 h] | 85,306.32 | MERZ B | 1 | 1 | BILL M | 10-028 |  |  |  |  |  |  |  |  |  |  |  |  |  |  |  |  |  |  |  |  |  |  |  |  |  |  |
| 13224030 |  | Proc LCW Manifolds/Hose for Arc & Septa PS (Installtn) | 60d | 2010-10-01 | 2011-01-04 | 9-110M, 121224999 | 434d | 110d |  | ELEC TECH [20 h]; PROCUREMENT<$50K 60 | 12,193.77 | MERZ B | 1 | 1 | BILL M | 10-028 |  |  |  |  |  |  |  |  |  |  |  |  |  |  |  |  |  |  |  |  |  |  |  |  |  |  |
| 13224040 |  | NAB Box Supply Infrastructure Installation Work | 80d | 2011-03-21 | 2011-07-12 | 16111030M | 488d | 154d |  | ELEC DES [40 h]; ELEC ENG [40 h]; SKLLD TRADE [880 h]; SUPPLIES & MATERIALS | 36,624.3 | MERZ B | 1 | 1 | BILL M | 10-028 |  |  |  | 11-055 | 12-029F | 12-050F |  |  |  |  |  |  |  |  |  |  |  |  |  |  |  |  |  |  |  |  |
| 13224040A |  | SAB Box Supply Infrastructure Installation Work | 80d | 2011-03-21 | 2011-07-12 | 16111030M | 488d | 468d |  | ELEC ENG [40 h]; SKLLD TRADE [880 h]; SUPPLIES & MATERIALS; ELEC DES [40 h] | 36,624.3 | MERZ B | 1 | 1 | BILL M | 10-028 | 12-028F |  |  |  | 12-029F |  |  |  |  |  |  |  |  |  |  |  |  |  |  |  |  |  |  |  |  |  |
| 13224045 |  | Pull/Terminate Box PS Load Cable (Installtn) Arc 10/West Arc FY11 (FY12 @ 13224047) | 98d | 2011-05-13 | 2011-09-30 | 4A-01M | 409d | 0d |  | ELEC DES [16.33 h]; ELEC ENG [16.33 h]; SKLLD TRADE [555.33 h] | 19,919.8 | MERZ B | 1 | 1 | BILL M | 10-028 | 12-028F |  |  |  | 12-029F |  | 12-001 | 12-035F |  |  |  |  |  |  |  |  |  |  |  |  |  |  |  |  |  |  |
| 13224085 |  | Pull/Terminate Trim Mag & Shunt Cable (Installtn) | 60d | 2011-05-13 | 2011-08-08 | 4A-01M | 581d | 404d |  | ELEC DES [20 h]; SKLLD TRADE [200 h]; ELEC TECH [80 h]; ELEC ENG [60 h] | 14,987.4 | MERZ B | 1 | 1 | BILL M | 10-028 | 12-028F | 08-041 |  |  |  |  |  |  |  |  |  |  |  |  |  |  |  |  |  |  |  |  |  |  |  |  |
| 13224002LOE |  | Installation Coordination FY12 | 247d | 2011-10-03 | 2012-09-28 | 13224001LOE | 237d | 0d |  | ELEC DES [456 h] | 23,032.56 | MERZ B | 1 | 1 | BILL M | 10-028 | 12-028F |  |  |  |  |  |  |  |  |  |  |  |  |  |  |  |  |  |  |  |  |  |  |  |  |  |
| 13224047 |  | Pull/Terminate Box PS Load Cable (Installtn) Arc 10/West Arc FY12 (FY11 @ 13224045) | 22d | 2011-10-03 | 2011-11-01 | 13224045 | 409d | 389d |  | ELEC ENG [3.67 h]; SKLLD TRADE [124.67 h]; ELEC DES [3.67 h] | 4,614.54 | MERZ B | 1 | 1 | BILL M | 10-028 | 12-028F |  |  |  | 12-029F |  | 12-001 | 12-035F |  |  |  |  |  |  |  |  |  |  |  |  |  |  |  |  |  |  |
| 13224050 |  | Pull/Terminate Arc & H-D Klixon Cable (Installtn) Frozen Per CR12-028 | 17d | 2012-02-06 | 2012-02-29 | 9-120M FS+81d, 16332030 FS+40d | 409d | 232d |  | ELEC TECH [34 h]; SKLLD TRADE [170 h]; ELEC DES [8.5 h]; ELEC ENG [8.5 h] | 8,216.02 | MERZ B | 1 | 1 | BILL M | 10-028 | 12-028 |  |  |  |  |  |  |  | 10-059 | 11-044 |  |  |  |  |  |  |  |  |  |  |  |  |  |  |  |  |
| 13224053 |  | Reverse Entry Per CR12-028 | 15d | 2012-03-05 | 2012-03-23 | 9-120M FS+100d | 132d |  |  | ELEC DES [-8.5 h]; ELEC TECH [-34 h]; SKLLD TRADE [-170 h]; ELEC ENG [-8.5 h] | -8,216.02 | MERZ B | 1 | 1 | BILL M | 10-028 | 12-028 |  |  |  |  |  |  |  | 10-059 | 11-044 |  |  |  |  |  |  |  |  |  |  |  |  |  |  |  |  |
| 13224044 |  | Label, Disconnect Pull Back SR Cables | 97d | 2012-05-14 | 2012-09-28 | 2-02M | 20d | 0d |  | SKLLD TRADE [120 h]; ELEC TECH [120 h] | 9,309.6 | MERZ B | 1 | 1 | BILL M | 10-028 | 12-028 |  |  |  |  |  |  | 12-035F |  |  |  |  |  |  |  |  |  |  |  |  |  |  |  |  |  |  |
| 13224075 |  | Install Trim Racks (Installtn) | 76d | 2012-05-14 | 2012-08-29 | 3A-21M, 3A-22M | 216d | 0d |  | SKLLD TRADE [120 h]; ELEC DES [20 h]; ELEC ENG [20 h] | 6,435.4 | MERZ B | 1 | 1 | BILL M | 10-028 | 12-028 |  |  |  |  |  |  |  |  |  |  |  |  |  |  |  |  |  |  |  |  |  |  |  |  |  |
| 13224080 |  | Install Trim Rack AC Pwr (Installtn) Part A | 97d | 2012-05-14 | 2012-09-28 | 13224075 FS-76d | 216d | 0d |  | SKLLD TRADE [400 h] | 13,380 | MERZ B | 1 | 1 | BILL M | 10-028 | 12-028 |  |  |  |  |  |  |  |  |  |  |  |  |  |  |  |  |  |  |  |  |  |  |  |  |  |
| 13224085B |  | Pull & Terminate Shunt Cable (Remove Old Cable)-Part A | 97d | 2012-05-14 | 2012-09-28 | 2-02M | 300d | 0d |  | ELEC TECH [240 h] | 10,591.2 | MERZ B | 1 | 1 | BILL M | 10-028 | 12-028 |  |  |  | 12-029F |  |  |  |  |  |  |  |  |  |  |  |  |  |  |  |  |  |  |  |  |  |
| 13224095 |  | Install Trim Comm/Controls Cable (Installtn) FY12 | 21d | 2012-08-30 | 2012-09-28 | 13224075 | 287d | 0d |  | ELEC TECH [350 h]; ELEC ENG [28 h]; ELEC DES [56 h] | 20,249.74 | MERZ B | 1 | 1 | BILL M | 10-028 | 12-028 |  |  |  |  |  |  |  |  |  | 12-053 |  |  |  |  |  |  |  |  |  |  |  |  |  |  |  |
| 13224003LOE |  | Installation Coordination FY13 *** Re-Baseline Split | 228d | 2012-10-01 | 2013-08-30 | 13224002LOE | 237d | 202d |  | ELEC ENG [367.74 h] | 26,775.15 | MERZ B | 1 | 1 | BILL M | 10-028 | 12-028 |  |  |  |  |  |  |  |  |  |  | 13-014 |  |  |  |  |  |  |  |  |  |  |  |  |  |  |
| 13224045A |  | Pull/Terminate Box PS Load Cable (Installtn) East Arc, S/R,BSY and Extraction | 164d | 2012-10-01 | 2013-05-31 | 13224044, 2-02M, 9-130M, 13221115 | 20d | 0d |  | SKLLD TRADE [200 h] | 6,904 | MERZ B | 1 | 1 | BILL M | 10-028 | 12-028 |  |  |  | 12-029F |  |  | 12-035F |  |  |  |  |  |  |  |  |  |  |  |  |  |  |  |  |  |  |
| 13224080A |  | Install Trim Rack AC Pwr (Installtn) Part B | 80d | 2012-10-01 | 2013-01-31 | 13224080 | 216d | 39d |  | SKLLD TRADE [400 h] | 13,808 | MERZ B | 1 | 1 | BILL M | 10-028 | 12-028 |  |  |  |  |  |  |  |  |  |  |  |  |  |  |  |  |  |  |  |  |  |  |  |  |  |
| 13224085A |  | Pull/Terminate Trim Mag (Installtn) East Arc , S/R and BSY | 80d | 2012-10-01 | 2013-01-31 | 2-02M, 9-130M | 216d | 39d |  | ELEC TECH [2200 h] | 100,188 | MERZ B | 1 | 1 | BILL M | 10-028 | 12-028 |  |  |  |  |  |  |  |  |  |  |  | 10-065 |  |  |  |  |  |  |  |  |  |  |  |  |  |
| 13224085C |  | Pull & Terminate Shunt Cable (Remove Old Cable)-Part B | 81d | 2012-10-01 | 2013-02-01 | 2-02M, 13224085B | 300d | 0d |  | ELEC TECH [320 h] | 14,572.8 | MERZ B | 1 | 1 | BILL M | 10-028 | 12-028 |  |  |  |  |  |  |  |  |  |  |  |  |  |  |  |  |  |  |  |  |  |  |  |  |  |
| 13224087 |  | BSY Serv. Bldg Infrastructure Installation- Tray, Power, Water, Controls | 63d | 2012-10-01 | 2013-01-07 | 9-130M | 318d | 18d |  | ELEC TECH [200 h]; ELEC ENG [40 h]; SKLLD TRADE [400 h] | 25,828.4 | MERZ B | 1 | 1 | BILL M | 10-028 | 12-028 |  |  |  |  |  |  |  |  |  |  |  |  |  |  |  |  |  |  |  |  |  |  |  |  |  |
| 13224090 |  | Pull/terminate/Connect Trim Mag Load Cable - H-D (Installtn) | 119d | 2012-10-01 | 2013-03-28 | 2-17M, 121224065, 13224052 FS-83d, 121224999, 13224050 FS-83d | 177d | 0d |  | ELEC ENG [20 h]; ELEC DES [20 h]; SKLLD TRADE [200 h] | 9,402.6 | MERZ B | 1 | 1 | BILL M | 10-028 | 12-028 |  |  |  |  |  |  |  | 10-059 | 11-044 |  |  |  |  |  |  |  |  |  |  |  |  |  |  |  |  |
| 13224095a |  | Install Trim Comm/Controls Cable (Installtn) FY13 | 9d | 2012-10-01 | 2012-10-11 | 13224095 | 287d | 110d |  | ELEC DES [24 h]; ELEC TECH [150 h]; ELEC ENG [12 h] | 8,955.6 | MERZ B | 1 | 1 | BILL M | 10-028 | 12-028 |  |  |  |  |  |  |  |  |  | 12-053 |  |  |  |  |  |  |  |  |  |  |  |  |  |  |  |
| 13224100 |  | Update/Install/Test Mag Controls Software (Installtn) | 150d | 2012-10-01 | 2013-05-10 | 9-130M, 2-02M | 108d |  |  | COMP SCIENT [480 h] | 32,500.8 | MERZ B | 1 | 1 | BILL M |  | 12-028 |  |  |  |  |  |  |  |  |  |  |  |  |  |  |  |  |  |  |  |  |  |  |  |  |  |
| 13224050A |  | Cable Tray Install Hall D Tunnel | 40d | 2012-12-03 | 2013-02-05 | 9-130M FS+43d | 101d | 81d |  | SKLLD TRADE [160 h] | 5,523.2 | MERZ B | 1 | 1 | BILL M | 10-028 | 12-028 |  |  |  |  |  |  |  | 10-059 | 11-044 |  |  |  |  |  |  |  |  |  |  |  |  |  |  |  |  |
| 13224052 |  | Pull/Terminate Arc & H-D Klixon Cable (Installtn) Revised Per CR12-028 | 40d | 2012-12-03 | 2013-02-05 | 9-130M FS+43d | 177d | 0d |  | ELEC TECH [80 h]; SKLLD TRADE [160 h] | 9,166.4 | MERZ B | 1 | 1 | BILL M | 10-028 | 12-028 |  |  |  |  |  |  |  | 10-059 | 11-044 |  |  |  |  |  |  |  |  |  |  |  |  |  |  |  |  |
| 13224110 |  | Intergation , Inspection, Test Trim PS (Installtn) | 69d | 2013-03-29 | 2013-07-05 | 13224095a, 13224080, 13224090, 13224085A, 13224080A, 13224085 | 177d | 142d |  | SUPPLIES & MATERIALS; ELEC ENG [40 h]; ELEC TECH [500 h]; ELEC DES [80 h] | 31,143.84 | MERZ B | 1 | 1 | BILL M | 10-028 | 12-028 |  |  |  |  |  |  |  |  |  |  |  |  |  |  |  |  |  |  |  |  |  |  |  |  |  |
| 13224055 |  | Connect Arc & Hall Mag Load & Klixon Cables (Installtn) *** Re-Baseline Split | 64d | 2013-06-03 | 2013-08-30 | 13224050A, 13221135 FS-58d, 13221115, 13224045A, 13224040, 13224047, 13224040A | 20d |  |  | SKLLD TRADE [83.48 h]; ELEC TECH [55.65 h] | 5,416.05 | MERZ B | 1 | 1 | BILL M | 10-028 | 12-028 |  |  |  | 12-029F |  |  |  |  |  |  | 13-014 |  |  |  |  |  |  |  |  |  |  |  |  |  |  |
| 13224115 |  | Re-Baseline Actuals Adjustment | 1d | 2013-08-30 | 2013-08-30 | 9-130M FS+227d | 20d |  |  | PROCUREMENT>$50K 69 NO ESCALATION | 483,126.98 | MERZ B | 1 | 1 | BILL M |  |  |  |  |  |  |  |  |  |  |  |  | 13-014 |  | ADJ |  |  |  |  |  |  |  |  |  |  |  |  |
| 23224003LOE |  | Installation Coordination FY13 | 20d | 2013-09-03 | 2013-09-30 | 9-130M FS+228d | 216d | 180d | 8/5 M-F w/JLAB Holidays ReBaseline | ELEC ENG [32.25 h] | 2,348.12 | MERZ B | 1 | 1 | BILL M | 10-028 | 12-028 |  |  |  |  |  |  |  |  |  |  |  |  |  | 23224003LOE | E | EJ | EJ | 13-015 | PR |  |  |  |  |  |  |
| 23224045A |  | Pull/Terminate Box PS Load Cable (Installtn) East Arc, S/R,BSY and Extraction Procurement | 47d | 2013-09-03 | 2013-11-06 | 9-130M FS+228d | 18d | 0d | 8/5 M-F w/JLAB Holidays ReBaseline | ELEC TECH; SUPPLIES & MATERIALS; SKLLD TRADE; PROCUREMENT<$50K 60 NO ESCALATION FY14 | 73.53 | MERZ B | 1 | 1 | BILL M | 10-028 | 12-028 |  |  |  | 12-029F |  |  | 12-035F |  |  |  |  |  |  | 23224045A | U | PE | EJ | 13-015 | PR | BSY tunnel may require additional effort and materials | y | NO | OB |  |  |
| 23224045Aa |  | Pull/Terminate Box PS Load Cable (Installtn) East Arc, S/R,BSY and Extraction Labor/Expenses FY13 | 20d | 2013-09-03 | 2013-09-30 | 9-130M FS+228d | 18d | 0d | 8/5 M-F w/JLAB Holidays ReBaseline | ELEC TECH [15.32 h]; SUPPLIES & MATERIALS; SKLLD TRADE [5.11 h] | 1,086.87 | MERZ B | 1 | 1 | BILL M | 10-028 | 12-028 |  |  |  | 12-029F |  |  | 12-035F |  |  |  |  |  |  | 23224045A | U | PE | EJ | 13-015 | PR | BSY tunnel may require additional effort and materials |  | NO |  |  |  |
| 23224055 |  | Connect Arc & Hall Mag Load & Klixon Cables (Installtn) FY13 | 20d | 2013-09-03 | 2013-09-30 | 23224045Ab FS-47d, 2813221005 FS-110d, 23224045A FS-47d, 2813221005a FS-110d, 23224045Aa FS-47d | 18d | 0d | 8/5 M-F w/JLAB Holidays ReBaseline | SKLLD TRADE [40.85 h]; ELEC TECH [27.24 h] | 2,650.61 | MERZ B | 1 | 1 | BILL M | 10-028 | 12-028 |  |  |  | 12-029F |  |  |  |  |  |  |  |  |  | 23224055 | U | PE | EJ | 13-015 | PR |  |  |  |  |  |  |
| 23224085A |  | Pull/Terminate Trim Mag (Installtn) East Arc , S/R and BSY FY13 | 20d | 2013-09-03 | 2013-09-30 | 9-130M FS+228d | 36d | 0d | 8/5 M-F w/JLAB Holidays ReBaseline | ELEC TECH [45.71 h] | 2,081.63 | MERZ B | 1 | 1 | BILL M | 10-028 | 12-028 |  |  |  |  |  |  |  |  |  |  |  | 10-065 |  | 23224085A | U | PE | EJ | 13-015 | PR | BSY tunnel may require additional effort and materials |  | NO |  |  |  |
| 23224087 |  | BSY Serv. Bldg Infrastructure Installation- Tray, Power, Water, Controls FY13 | 20d | 2013-09-03 | 2013-09-30 | 9-130M FS+228d | 283d | 0d | 8/5 M-F w/JLAB Holidays ReBaseline | ELEC ENG [9.52 h]; SKLLD TRADE [95.24 h]; SUPPLIES & MATERIALS; ELEC TECH [47.62 h] | 9,721.01 | MERZ B | 1 | 1 | BILL M | 10-028 | 12-028 |  |  |  |  |  |  |  |  |  |  |  |  |  | 23224087 | S | EJ | EJ | 13-015 | PR | Extent of upgrades may be greater than planned |  | NO |  | ST |  |
| 23224100 |  | Update/Install/Test Mag Controls Software (Installtn) FY13 | 20d | 2013-09-03 | 2013-09-30 | 9-130M FS+228d | 25d | 0d | 8/5 M-F w/JLAB Holidays ReBaseline | COMP SCIENT [93.87 h] | 6,355.94 | MERZ B | 1 | 1 | BILL M |  | 12-028 |  |  |  |  |  |  |  |  |  |  |  |  |  | 23224100 | S | PE | EJ | 13-015 | PR |  |  |  |  | ST |  |
| 23224045Ab |  | Pull/Terminate Box PS Load Cable (Installtn) East Arc, S/R,BSY and Extraction Labor/Expenses FY14 | 27d | 2013-10-01 | 2013-11-06 | 23224045Aa, 9-130M FS+228d | 18d | 0d | 8/5 M-F w/JLAB Holidays ReBaseline | ELEC TECH [20.68 h]; SUPPLIES & MATERIALS; SKLLD TRADE [6.89 h] | 1,513.98 | MERZ B | 1 | 1 | BILL M | 10-028 | 12-028 |  |  |  | 12-029F |  |  | 12-035F |  |  |  |  |  |  | 23224045A | U | PE | EJ | 13-015 | PR | BSY tunnel may require additional effort and materials |  | NO |  |  | 14-001 |
| 23224055a |  | Connect Arc & Hall Mag Load & Klixon Cables (Installtn) FY14 | 27d | 2013-10-01 | 2013-11-06 | 2813221005a FS-110d, 23224045Ab FS-47d, 23224045A FS-47d, 23224045Aa FS-47d, 23224055, 2813221005 FS-110d | 18d | 0d | 8/5 M-F w/JLAB Holidays ReBaseline | SKLLD TRADE [55.15 h]; ELEC TECH [36.77 h] | 3,692.24 | MERZ B | 1 | 1 | BILL M | 10-028 | 12-028 |  |  |  | 12-029F |  |  |  |  |  |  |  |  |  | 23224055 | U | PE | EJ | 13-015 | PR |  |  |  |  |  | 14-001 |
| 23224085Aa |  | Pull/Terminate Trim Mag (Installtn) East Arc , S/R and BSY FY14 | 22d | 2013-10-01 | 2013-10-30 | 23224085A, 9-130M FS+228d | 36d | 0d | 8/5 M-F w/JLAB Holidays ReBaseline | ELEC TECH [50.29 h] | 2,363.13 | MERZ B | 1 | 1 | BILL M | 10-028 | 12-028 |  |  |  |  |  |  |  |  |  |  |  | 10-065 |  | 23224085A | U | PE | EJ | 13-015 | PR | BSY tunnel may require additional effort and materials |  | NO |  |  | 14-001 |
| 23224087a |  | BSY Serv. Bldg Infrastructure Installation- Tray, Power, Water, Controls FY14 | 22d | 2013-10-01 | 2013-10-30 | 9-130M FS+228d, 23224087 | 283d |  | 8/5 M-F w/JLAB Holidays ReBaseline | ELEC TECH [52.38 h]; ELEC ENG [10.48 h]; SKLLD TRADE [104.76 h]; SUPPLIES & MATERIALS | 11,034 | MERZ B | 1 | 1 | BILL M | 10-028 | 12-028 |  |  |  |  |  |  |  |  |  |  |  |  |  | 23224087 | S | EJ | EJ | 13-015 | PR | Extent of upgrades may be greater than planned |  | NO |  | ST | 14-001 |
| 23224100a |  | Update/Install/Test Mag Controls Software (Installtn) FY14 | 25d | 2013-10-01 | 2013-11-04 | 23224100, 9-130M FS+228d | 25d |  | 8/5 M-F w/JLAB Holidays ReBaseline | COMP SCIENT [117.34 h] | 8,198.55 | MERZ B | 1 | 1 | BILL M |  | 12-028 |  |  |  |  |  |  |  |  |  |  |  |  |  | 23224100 | S | PE | EJ | 13-015 | PR |  |  |  |  | ST | 14-001 |

Notes:
- 13224045: Entry Criteria: magnets removed, tunnel clear
- 13224085: Entry Criteria: magnets removed for pull, magnets in / place to connect & terminate
- 13224047: Entry Criteria: magnets removed, tunnel clear
- 13224050: Entry Criteria: magnets removed, tunnel / clear
- 13224053: Entry Criteria: magnets removed, tunnel / clear
- 13224044: Entry Criteria: magnets removed, tunnel clear
- 13224085B: Entry Criteria: magnets removed for pull, magnets in / place to connect & terminate
- 13224045A: Entry Criteria: magnets removed, tunnel clear
- 13224085A: Entry Criteria: magnets removed for pull, magnets in / place to connect & terminate
- 13224085C: Entry Criteria: magnets removed for pull, magnets in / place to connect & terminate
- 13224087: Entry Criteria: magnets removed for pull, magnets in / place to connect & terminate
- 13224090: Entry Criteria: magnets removed for pull, magnets in / place to connect & terminate
- 13224050A: Entry Criteria: magnets removed, tunnel / clear
- 13224052: Entry Criteria: magnets removed, tunnel / clear
- 13224055: Entry Criteria: magnets installed
- 23224045A: Entry Criteria: magnets removed, tunnel clear
- 23224045Aa: Entry Criteria: magnets removed, tunnel clear
- 23224055: Entry Criteria: magnets installed
- 23224085A: Entry Criteria: magnets removed for pull, magnets in / place to connect & terminate
- 23224087: Entry Criteria: magnets removed for pull, magnets in / place to connect & terminate / Steps: LCW; Control wiring; AC Pwr; DC Cable
- 23224100: Steps: Box Software Complete; Shunts Software Complete; Trims Software Complete; Test
- 23224045Ab: Entry Criteria: magnets removed, tunnel clear
- 23224055a: Entry Criteria: magnets installed
- 23224085Aa: Entry Criteria: magnets removed for pull, magnets in / place to connect & terminate
- 23224087a: Entry Criteria: magnets removed for pull, magnets in / place to connect & terminate / Steps: LCW; Control wiring; AC Pwr; DC Cable
- 23224100a: Steps: Box Software Complete; Shunts Software Complete; Trims Software Complete; Test

| ID | WBS | Activity | Duration | Start | Finish | Predecessors | Total float | Free float | Resources | Cost | RESP - Responsibility | STRT%COMP for CM EVM | FNSH%COMP for CM EVM | Profile change | Advance Purchase Plan > 500K | CR 08-016 | CAM RESPONSIBLE | 12 GEV MAJOR PROCUREMENT CATAGORY | Duplications | CR 09-012 | CR 10-039 | CR 07-024 | Schedule Contingency | CR 13-014 | ReBaseline Actuals Adjustment |
| --- | --- | --- | --- | --- | --- | --- | --- | --- | --- | --- | --- | --- | --- | --- | --- | --- | --- | --- | --- | --- | --- | --- | --- | --- | --- |
|  | 3 | **1.3.3 CRYOGENICS** |  | 2009-01-05 | 2013-09-30 |  |  |  |  |  |  |  |  |  |  |  |  |  |  |  |  |  |  |  |  |
|  | 1 | **1.3.3.1 ACCELERATOR** |  | 2009-01-05 | 2013-09-30 |  |  |  |  |  |  |  |  |  |  |  |  |  |  |  |  |  |  |  |  |
|  | 01 | **1.3.3.1.01 COMPRESSORS** |  | 2010-01-05 | 2013-08-30 |  |  |  |  |  |  |  |  |  |  |  |  |  |  |  |  |  |  |  |  |
| 1331.01000 |  | Vend Production CHL Helium Compressors (Original Labor) | 37d | 2010-01-05 | 2010-02-26 | 12131.03020, 12131.03015, 1331.02000 FS-125d, 9-100M FS+60d | 109d | 5d | MECH DES [24.16 h]; ELEC ENG [24.16 h]; TRAVEL; ELEC DES [24.16 h]; MECH ENG [24.16 h] | 6,593.48 | ARENIUS D | 1 | 1 | C | APP | 08-016 | DANA A | 3311 | DUP | 09-012 | 10-039 |  |  |  |  |
| 1331.01005 |  | Vend Production CHL Helium Compressors Oversight FY10 | 146d | 2010-03-08 | 2010-09-30 | 9-100M FS+102d, 1331.01000 | 104d | 0d | TRAVEL; ELEC TECH [102.5 h]; ELEC DES [58 h]; ELEC ENG [58 h]; MECH DES [58 h]; MECH ENG [58 h]; MECH TECH [273 h] | 35,243.45 | ARENIUS D | 1 | 1 | C | APP |  | DANA A | 3311 | DUP |  | 10-039 | 07-024 |  |  |  |
| 1331.01010 |  | Vend Fab CHL Helium Compressors Peg Point #1 Complete Preliminary Design Review | 40d | 2010-03-08 | 2010-04-30 | 9-100M FS+102d | 31d | 0d | PROCUREMENT<$50K 60 NO ESCALATION; PROCUREMENT>$50K 69 NO ESCALATION | 138,308.78 | ARENIUS D | 1 | 1 | C | APP |  | DANA A | 3311 |  |  | 10-039 |  |  |  |  |
| 1331.01015 |  | Vend Fab CHL Helium Compressors Peg Point #2 Placement of Order for Coolers | 40d | 2010-03-08 | 2010-04-30 | 1331.01010 FS-40d | 40d | 0d | PROCUREMENT>$50K 69 NO ESCALATION | 110,647.02 | ARENIUS D | 1 | 1 | C | APP |  | DANA A | 3311 |  |  | 10-039 |  |  |  |  |
| 1331.01020 |  | Vend Fab CHL Helium Compressors Peg Point #3 Placement of Order for Compressors | 40d | 2010-03-08 | 2010-04-30 | 1331.01015 FS-40d | 40d | 0d | PROCUREMENT>$50K 69 NO ESCALATION | 313,499.89 | ARENIUS D | 1 | 1 | C | APP |  | DANA A | 3311 |  |  | 10-039 |  |  |  |  |
| 1331.01025 |  | Vend Fab CHL Helium Compressors Peg Point #4 Placement of Order for Heat Exchangers | 60d | 2010-03-08 | 2010-05-28 | 1331.01020 FS-40d | 40d | 0d | PROCUREMENT>$50K 69 NO ESCALATION | 204,696.99 | ARENIUS D | 1 | 1 | C | APP |  | DANA A | 3311 |  |  | 10-039 |  |  |  |  |
| 1331.01030 |  | Vend Fab CHL Helium Compressors Peg Point #5 Placement of Order for Motors | 60d | 2010-03-08 | 2010-05-28 | 1331.01025 FS-60d | 40d | 0d | PROCUREMENT>$50K 69 NO ESCALATION | 313,499.89 | ARENIUS D | 1 | 1 | C | APP |  | DANA A | 3311 |  |  | 10-039 |  |  |  |  |
| 1331.01035 |  | Vend Fab CHL Helium Compressors Peg Point #6 CDR Complete | 82d | 2010-03-08 | 2010-06-30 | 1331.01030 FS-60d | 40d | 0d | PROCUREMENT>$50K 69 NO ESCALATION | 138,308.78 | ARENIUS D | 1 | 1 | C | APP |  | DANA A | 3311 |  |  | 10-039 |  |  |  |  |
| 1331.01040 |  | Vend Fab CHL Helium Compressors Peg Point #7 Final Drawing Approval | 125d | 2010-03-08 | 2010-08-31 | 1331.01035 FS-82d | 40d | 0d | PROCUREMENT>$50K 69 NO ESCALATION | 184,411.7 | ARENIUS D | 1 | 1 | C | APP |  | DANA A | 3311 |  |  | 10-039 |  | SC |  |  |
| 1331.01045 |  | Vend Fab CHL Helium Compressors Peg Point #8 Receipt of Compressors | 146d | 2010-03-08 | 2010-09-30 | 1331.01040 FS-125d | 40d | 0d | PROCUREMENT>$50K 69 NO ESCALATION | 424,146.91 | ARENIUS D | 1 | 1 | C | APP |  | DANA A | 3311 |  |  | 10-039 |  | SC |  |  |
| 1331.01050 |  | Vend Fab CHL Helium Compressors Peg Point #9 Receipt of Motors | 167d | 2010-03-08 | 2010-10-29 | 1331.01045 FS-146d | 40d | 0d | PROCUREMENT>$50K 69 NO ESCALATION | 424,146.91 | ARENIUS D | 1 | 1 | C | APP |  | DANA A | 3311 |  |  | 10-039 |  | SC |  |  |
| 1331.01055 |  | Vend Fab CHL Helium Compressors Peg Point #10 Receipt of Heat Exchangers | 167d | 2010-03-08 | 2010-10-29 | 1331.01050 FS-167d | 40d | 0d | PROCUREMENT>$50K 69 NO ESCALATION | 238,813.15 | ARENIUS D | 1 | 1 | C | APP |  | DANA A | 3311 |  |  | 10-039 |  | SC |  |  |
| 1331.01060 |  | Vend Fab CHL Helium Compressors Peg Point #11 Receipt of Coolers | 204d | 2010-03-08 | 2010-12-30 | 1331.01055 FS-167d | 40d | 0d | PROCUREMENT>$50K 69 NO ESCALATION | 238,813.15 | ARENIUS D | 1 | 1 | C | APP |  | DANA A | 3311 |  |  | 10-039 |  | SC |  |  |
| 1331.01065 |  | Vend Fab CHL Helium Compressors Peg Point #12 Complete Installation of Motors | 224d | 2010-03-08 | 2011-01-31 | 1331.01060 FS-204d | 40d | 0d | PROCUREMENT>$50K 69 NO ESCALATION | 276,617.55 | ARENIUS D | 1 | 1 | C | APP |  | DANA A | 3311 |  |  | 10-039 |  | SC |  |  |
| 1331.01070 |  | Vend Fab CHL Helium Compressors Peg Point #13 Complete Installation of Compressors | 224d | 2010-03-08 | 2011-01-31 | 1331.01065 FS-224d | 40d | 0d | PROCUREMENT>$50K 69 NO ESCALATION | 258,176.38 | ARENIUS D | 1 | 1 | C | APP |  | DANA A | 3311 |  |  | 10-039 |  | SC |  |  |
| 1331.01075 |  | Vend Fab CHL Helium Compressors Peg Point #14 Complete Installation of Coolers | 224d | 2010-03-08 | 2011-01-31 | 1331.01070 FS-224d | 40d | 0d | PROCUREMENT>$50K 69 NO ESCALATION | 92,205.85 | ARENIUS D | 1 | 1 | C | APP |  | DANA A | 3311 |  |  | 10-039 |  | SC |  |  |
| 1331.01080 |  | Vend Fab CHL Helium Compressors Peg Point #15 Complete Installation of Heat Exchangers | 243d | 2010-03-08 | 2011-02-28 | 1331.01075 FS-224d | 40d | 0d | PROCUREMENT>$50K 69 NO ESCALATION | 92,205.85 | ARENIUS D | 1 | 1 | C | APP |  | DANA A | 3311 |  |  | 10-039 |  | SC |  |  |
| 1331.01085 |  | Vend Fab CHL Helium Compressors Peg Point #16 System Pressure, Leak Test | 243d | 2010-03-08 | 2011-02-28 | 1331.01080 FS-243d | 40d | 0d | PROCUREMENT>$50K 69 NO ESCALATION | 92,205.85 | ARENIUS D | 1 | 1 | C | APP |  | DANA A | 3311 |  |  | 10-039 |  | SC |  |  |
| 1331.01090 |  | Vend Fab CHL Helium Compressors Peg Point #17 Installation of Electrical Panels, Instruments and Devices | 243d | 2010-03-08 | 2011-02-28 | 1331.01085 FS-243d | 40d | 0d | PROCUREMENT>$50K 69 NO ESCALATION | 92,205.85 | ARENIUS D | 1 | 1 | C | APP |  | DANA A | 3311 |  |  | 10-039 |  | SC |  |  |
| 1331.01095 |  | Vend Fab CHL Helium Compressors Peg Point #18 Spare Parts Received by JLab | 266d | 2010-03-08 | 2011-03-31 | 1331.01090 FS-243d | 40d | 0d | PROCUREMENT>$50K 69 NO ESCALATION | 57,206.7 | ARENIUS D | 1 | 1 | C | APP |  | DANA A | 3311 |  |  | 10-039 |  | SC |  |  |
| 1331.01100 |  | Vend Fab CHL Helium Compressors Peg Point #19 Complete User Rediness Review | 350d | 2010-03-08 | 2011-07-29 | 1331.01095 FS-266d | 40d | 0d | PROCUREMENT>$50K 69 NO ESCALATION | 18,441.17 | ARENIUS D | 1 | 1 | C | APP |  | DANA A | 3311 |  |  | 10-039 |  | SC |  |  |
| 1331.01105 |  | Vend Fab CHL Helium Compressors Peg Point #20 Completion of Compressor System Commissioning | 350d | 2010-03-08 | 2011-07-29 | 1331.01100 FS-350d | 40d | 0d | PROCUREMENT>$50K 69 NO ESCALATION | 18,441.17 | ARENIUS D | 1 | 1 | C | APP |  | DANA A | 3311 |  |  | 10-039 |  | SC |  |  |
| 1331.01110 |  | Vend Fab CHL Helium Compressors Peg Point #21 Completion of System Acceptance Testing and Report | 394d | 2010-03-08 | 2011-09-30 | 1331.01105 FS-350d | 40d | 0d | PROCUREMENT>$50K 69 NO ESCALATION | 18,441.16 | ARENIUS D | 1 | 1 | C | APP |  | DANA A | 3311 |  |  | 10-039 |  | SC |  |  |
| 1331.01005A |  | Vend Production CHL Helium Compressors Oversight FY11 | 184d | 2010-10-01 | 2011-06-30 | 1331.01005 | 104d | 64d | ELEC ENG [77.84 h]; MECH DES [77.84 h]; MECH ENG [77.84 h]; MECH TECH [367 h]; TRAVEL; ELEC TECH [137.5 h]; ELEC DES [77.84 h] | 46,514.04 | ARENIUS D | 1 | 1 | C | APP |  | DANA A | 3311 |  |  | 10-039 |  |  |  |  |
| 1331.01115 |  | Re-Baseline Actuals Adjustment | 1d | 2013-08-30 | 2013-08-30 | 9-130M FS+227d | 20d |  | PROCUREMENT>$50K 69 NO ESCALATION | 303,464.42 | ARENIUS D | 1 | 1 |  |  |  | DANA A |  |  |  |  |  |  | 13-014 | ADJ |

Notes:
- 1331.01000: Entry Criteria: Ext Pred: Completion of ACD
- 1331.01005: Entry Criteria: Ext Pred: Completion of ACD
- 1331.01010: Entry Criteria: Ext Pred: Completion of ACD
- 1331.01015: Entry Criteria: Ext Pred: Completion of ACD
- 1331.01020: Entry Criteria: Ext Pred: Completion of ACD
- 1331.01025: Entry Criteria: Ext Pred: Completion of ACD
- 1331.01030: Entry Criteria: Ext Pred: Completion of ACD
- 1331.01035: Entry Criteria: Ext Pred: Completion of ACD
- 1331.01040: Entry Criteria: Ext Pred: Completion of ACD
- 1331.01045: Entry Criteria: Ext Pred: Completion of ACD
- 1331.01050: Entry Criteria: Ext Pred: Completion of ACD
- 1331.01055: Entry Criteria: Ext Pred: Completion of ACD
- 1331.01060: Entry Criteria: Ext Pred: Completion of ACD
- 1331.01065: Entry Criteria: Ext Pred: Completion of ACD
- 1331.01070: Entry Criteria: Ext Pred: Completion of ACD
- 1331.01075: Entry Criteria: Ext Pred: Completion of ACD
- 1331.01080: Entry Criteria: Ext Pred: Completion of ACD
- 1331.01085: Entry Criteria: Ext Pred: Completion of ACD
- 1331.01090: Entry Criteria: Ext Pred: Completion of ACD
- 1331.01095: Entry Criteria: Ext Pred: Completion of ACD
- 1331.01100: Entry Criteria: Ext Pred: Completion of ACD
- 1331.01105: Entry Criteria: Ext Pred: Completion of ACD
- 1331.01110: Entry Criteria: Ext Pred: Completion of ACD
- 1331.01005A: Entry Criteria: Ext Pred: Completion of ACD

| ID | WBS | Activity | Duration | Start | Finish | Predecessors | Total float | Free float | Resources | Cost | RESP - Responsibility | STRT%COMP for CM EVM | FNSH%COMP for CM EVM | Profile change | Advance Purchase Plan > 500K | CR 08-016 | CAM RESPONSIBLE | 12 GEV MAJOR PROCUREMENT CATAGORY | CR 09-012 | CR 09-053 | CR 12-018 | CR 12-029 | CR 10-038 | CR 10-055 | EVMS Reporting Codes | CR 11-008 | Activities with Steps | CR 12-002 | CR 13-014 | ReBaseline Actuals Adjustment |
| --- | --- | --- | --- | --- | --- | --- | --- | --- | --- | --- | --- | --- | --- | --- | --- | --- | --- | --- | --- | --- | --- | --- | --- | --- | --- | --- | --- | --- | --- | --- |
|  | 02 | **1.3.3.1.02 COLD BOXES** |  | 2009-01-05 | 2013-08-30 |  |  |  |  |  |  |  |  |  |  |  |  |  |  |  |  |  |  |  |  |  |  |  |  |  |
| 1331.02000 |  | FY-09 Initial Labor (Planned) Procurement Support | 188d | 2009-01-05 | 2009-09-30 | 12131.04020, 9-090M FS+60d | 0d |  | MECH DES [151.61 h]; TRAVEL; SUPPLIES & MATERIALS; ELEC DES [90.97 h]; ELEC TECH [90.97 h]; MECH TECH [272.9 h]; MECH ENG [151.61 h] | 44,649.29 | ARENIUS D | 1 | 1 | C | APP | 08-016 | DANA A | 3312 | 09-012 | 09-053 |  |  |  |  |  |  |  |  |  |  |
| 1331.02015 |  | Vend Fab- Peg Point 1: Contract Award | 1d | 2009-09-30 | 2009-09-30 | 1331.02000 FS-1d | 0d |  | PROCUREMENT<$50K 60 NO ESCALATION; PROCUREMENT>$50K 69 NO ESCALATION | 529,000 | ARENIUS D | 1 | 1 | C | APP |  | DANA A | 3312 |  | 09-053 |  |  |  |  |  |  |  |  |  |  |
| 1331.02020 |  | Vend Fab- Peg Point 3: Issue PO for Platefin Heat Exchangers& Absorbers | 79d | 2009-09-30 | 2010-01-29 | 1331.02015 FS-1d | 0d |  | PROCUREMENT>$50K 69 NO ESCALATION | 529,000 | ARENIUS D | 1 | 1 | C | APP |  | DANA A | 3312 |  | 09-053 |  |  |  |  |  |  |  |  |  |  |
| 1331.02025 |  | Vend Fab- Peg Point 2: Complete Preliminary Design Review | 79d | 2009-09-30 | 2010-01-29 | 1331.02015 FS-1d, 1331.02020 FS-79d | 0d |  | PROCUREMENT>$50K 69 NO ESCALATION | 1,058,000 | ARENIUS D | 1 | 1 | C | APP |  | DANA A | 3312 |  | 09-053 |  |  |  |  |  |  |  |  |  |  |
| 1331.02030 |  | Vend Fab- Peg Point 4: Issue PO for Turbines & Cryogenic Valves | 143d | 2009-09-30 | 2010-04-30 | 1331.02025 FS-79d, 1331.02015 FS-1d | 40d | 0d | PROCUREMENT>$50K 69 NO ESCALATION | 529,000 | ARENIUS D | 1 | 1 | C | APP |  | DANA A | 3312 |  | 09-053 |  |  |  |  |  |  |  |  |  |  |
| 1331.02035 |  | Vend Fab- Peg Point 7: Deliver Platefin Heat Exchangers& Absorbers | 249d | 2009-09-30 | 2010-09-30 | 1331.02030 FS-143d, 1331.02015 FS-1d | 40d | 0d | PROCUREMENT>$50K 69 NO ESCALATION | 1,058,000 | ARENIUS D | 1 | 1 | C | APP |  | DANA A | 3312 |  | 09-053 |  |  |  |  |  |  |  |  |  |  |
| 1331.02040 |  | Vend Fab- Peg Point 4: Issue PO for Cold Box Shell | 249d | 2009-09-30 | 2010-09-30 | 1331.02035 FS-249d, 1331.02015 FS-1d | 40d | 0d | PROCUREMENT>$50K 69 NO ESCALATION | 529,000 | ARENIUS D | 1 | 1 | C | APP |  | DANA A | 3312 |  | 09-053 |  |  |  |  |  |  |  |  |  |  |
| 1331.02045 |  | Vend Fab- Peg Point 8: Deliver Turbine Housing | 290d | 2009-09-30 | 2010-11-30 | 1331.02015 FS-1d, 1331.02040 FS-249d | 40d | 0d | PROCUREMENT>$50K 69 NO ESCALATION | 952,200 | ARENIUS D | 1 | 1 | C | APP |  | DANA A | 3312 |  | 09-053 |  |  |  |  |  |  |  |  |  |  |
| 1331.02050 |  | Vend Fab- Peg Point 5: Complete Final Design Review | 308d | 2009-09-30 | 2010-12-31 | 1331.02015 FS-1d, 1331.02045 FS-290d | 40d | 0d | PROCUREMENT>$50K 69 NO ESCALATION | 529,000 | ARENIUS D | 1 | 1 | C | APP |  | DANA A | 3312 |  | 09-053 |  |  |  |  |  |  |  |  |  |  |
| 1331.02055 |  | Vend Fab- Peg Point 10: Complete Internal Piping | 433d | 2009-09-30 | 2011-06-30 | 1331.02050 FS-308d, 1331.02015 FS-1d | 40d | 0d | PROCUREMENT>$50K 69 NO ESCALATION | 952,200 | ARENIUS D | 1 | 1 | C | APP |  | DANA A | 3312 |  | 09-053 |  |  |  |  |  |  |  |  |  |  |
| 1331.02060 |  | Vend Fab- Peg Point 9: Complete Cold Box Shell | 433d | 2009-09-30 | 2011-06-30 | 1331.02055 FS-433d, 1331.02015 FS-1d | 40d | 0d | PROCUREMENT>$50K 69 NO ESCALATION | 952,200 | ARENIUS D | 1 | 1 | C | APP |  | DANA A | 3312 |  | 09-053 |  |  |  |  |  |  |  |  |  |  |
| 1331.02065 |  | Vend Fab- Peg Point 11: Ship Cold Box | 476d | 2009-09-30 | 2011-08-31 | 1331.02060 FS-433d, 1331.02090 FS-476d, 1331.02085 FS-108d, 1331.02015 FS-1d | 40d | 0d | PROCUREMENT>$50K 69 NO ESCALATION | 1,481,200 | ARENIUS D | 1 | 1 | C | APP |  | DANA A | 3312 |  | 09-053 |  |  |  |  |  |  |  |  |  |  |
| 1331.02070 |  | Vend Fab- Peg Point 12: Complete Installation | 497d | 2009-09-30 | 2011-09-30 | 1331.02065 FS-476d, 1331.02015 FS-1d, 1331.02068 FS-497d | 40d | 0d | PROCUREMENT>$50K 69 NO ESCALATION | 423,200 | ARENIUS D | 1 | 1 | C | APP |  | DANA A | 3312 |  | 09-053 |  |  |  |  |  |  |  |  |  |  |
| 1331.02075 |  | Vend Fab- Peg Point 14: Deliver Final Operating & Maintenance Manuals | 518d | 2009-09-30 | 2011-10-31 | 1331.02070 FS-497d, 1331.02015 FS-1d | 418d | 0d | PROCUREMENT>$50K 69 NO ESCALATION | 211,600 | ARENIUS D | 1 | 1 | C | APP |  | DANA A | 3312 |  | 09-053 | 12-018F | 12-029F |  |  |  |  |  |  |  |  |
| 1331.02080 |  | Vend Fab- Peg Point 13: Acceptance Test Complete & Report Delivered | 617d | 2009-09-30 | 2012-03-30 | 1331.02075 FS-518d, 1331.02015 FS-1d | 418d | 384d | PROCUREMENT>$50K 69 NO ESCALATION | 846,400 | ARENIUS D | 1 | 1 | C | APP |  | DANA A | 3312 |  | 09-053 | 12-018F | 12-029F |  |  |  |  |  |  |  |  |
| 1331.02001 |  | FY-10 Labor Procurement Support | 248d | 2009-10-01 | 2010-09-30 | 1331.02000, 9-100M | 113d | 0d | MECH DES [132.21 h]; SUPPLIES & MATERIALS; ELEC DES [92.21 h]; ELEC TECH [92.21 h]; MECH TECH [276.63 h]; MECH ENG [132.21 h]; TRAVEL | 44,552.59 | ARENIUS D | 1 | 1 | C | APP |  | DANA A | 3312 |  | 09-053 |  |  |  |  |  |  |  |  |  |  |
| 1331.02012 |  | He Dewar Procurement | 152d | 2009-10-15 | 2010-05-28 | 9-100M FS+10d | 374d | 334d | PROCUREMENT>$50K 69 NO ESCALATION; PROCUREMENT<$50K 60 NO ESCALATION | 123,000 | ARENIUS D | 1 | 1 | C | APP |  | DANA A | 3312 |  | 09-053 |  |  |  |  |  |  |  |  |  |  |
| 1331.02085 |  | Additional Funds for Currency Exchange Rate | 10d | 2010-03-01 | 2010-03-12 | 9-100M FS+97d | 40d | 0d | PROCUREMENT>$50K 69 NO ESCALATION; PROCUREMENT<$50K 60 NO ESCALATION | 255,826 | ARENIUS D | 1 | 1 | C | APP |  | DANA A | 3312 |  |  |  |  | 10-038 |  |  |  |  |  |  |  |
| 1331.02090 |  | Spare Turbine and Seal Kits | 65d | 2010-03-01 | 2010-05-28 | 9-100M FS+97d | 353d | 313d | PROCUREMENT>$50K 69 NO ESCALATION; PROCUREMENT<$50K 60 NO ESCALATION | 690,785 | ARENIUS D | 1 | 1 | C | APP |  | DANA A | 3312 |  |  |  |  | 10-038 | 10-055 |  |  |  |  |  |  |
| 1331.02005 |  | FY-11 Labor Procurement Support | 248d | 2010-10-01 | 2011-09-30 | 9-100M FS+60d, 32-02M, 1331.02000, 1331.02001 | 295d | 0d | MECH TECH [276.63 h]; ELEC TECH [92.21 h]; SUPPLIES & MATERIALS; MECH ENG [132.21 h]; MECH DES [132.21 h]; ELEC DES [92.21 h]; TRAVEL | 45,972.39 | ARENIUS D | 1 | 1 | C | APP | 08-016 | DANA A | 3312 | 09-012 | 09-053 |  |  |  |  |  |  |  |  |  |  |
| 1331.02052 |  | Vend Fab- Peg Point 15: Venturi Flow Measurement | 38d | 2011-01-04 | 2011-02-28 | 1331.02050 | 40d | 0d | PROCUREMENT<$50K 60 NO ESCALATION | 33,800 | ARENIUS D | 1 | 1 | C | APP |  | DANA A | 3312 |  |  |  |  |  |  | P | 11-008 |  |  |  |  |
| 1331.02068 |  | Vend Fab- Peg Point 16: Re-rout Transfer Lines | 189d | 2011-01-04 | 2011-09-30 | 1331.02052 FS-38d, 1331.02065 FS-168d | 40d | 0d | PROCUREMENT<$50K 60 NO ESCALATION; PROCUREMENT>$50K 69 NO ESCALATION | 97,200 | ARENIUS D | 1 | 1 | C |  |  | DANA A | 3312 |  |  |  |  |  |  | P | 11-008 | ST |  |  |  |
| 1331.02010 |  | FY-12 Labor Procurement Support | 120d | 2011-10-03 | 2012-03-30 | 1331.02005, 9-110M FS+60d | 295d | 242d | MECH DES [63.97 h]; MECH TECH [133.85 h]; SUPPLIES & MATERIALS; ELEC DES [44.62 h]; ELEC TECH [44.62 h]; MECH ENG [63.97 h]; TRAVEL | 26,358.04 | ARENIUS D | 1 | 1 |  | APP | 08-016 | DANA A | 3312 | 09-012 | 09-053 |  |  |  |  |  |  |  |  |  |  |
| 1331.02066 |  | Vend Fab- Peg Point 17: Cold Box Shipping Costs | 37d | 2011-11-01 | 2011-12-30 | 1331.02065 FS+42d | 480d | 446d | PROCUREMENT<$50K 60 NO ESCALATION; PROCUREMENT>$50K 69 NO ESCALATION | 250,000 | ARENIUS D | 1 | 1 | C | APP |  | DANA A | 3312 |  | 09-053 | 12-018F | 12-029F |  |  |  |  |  | 12-002 |  |  |
| 1331.02100 |  | Re-Baseline Actuals Adjustment | 1d | 2013-08-30 | 2013-08-30 | 9-130M FS+227d | 20d |  | PROCUREMENT>$50K 69 NO ESCALATION | 210,640.2 | ARENIUS D | 1 | 1 |  |  |  | DANA A |  |  |  |  |  |  |  |  |  |  |  | 13-014 | ADJ |

Notes:
- 1331.02000: Entry Criteria: Ext Pred: Completion of ACD
- 1331.02015: Entry Criteria: Ext Pred: Completion of ACD
- 1331.02020: Entry Criteria: Ext Pred: Completion of ACD
- 1331.02025: Entry Criteria: Ext Pred: Completion of ACD
- 1331.02030: Entry Criteria: Ext Pred: Completion of ACD
- 1331.02035: Entry Criteria: Ext Pred: Completion of ACD
- 1331.02040: Entry Criteria: Ext Pred: Completion of ACD
- 1331.02045: Entry Criteria: Ext Pred: Completion of ACD
- 1331.02050: Entry Criteria: Ext Pred: Completion of ACD
- 1331.02055: Entry Criteria: Ext Pred: Completion of ACD
- 1331.02060: Entry Criteria: Ext Pred: Completion of ACD
- 1331.02065: Entry Criteria: Ext Pred: Completion of ACD
- 1331.02070: Entry Criteria: Ext Pred: Completion of ACD
- 1331.02075: Entry Criteria: Ext Pred: Completion of ACD
- 1331.02080: Entry Criteria: Ext Pred: Completion of ACD
- 1331.02001: Entry Criteria: Ext Pred: Completion of ACD
- 1331.02012: Entry Criteria: Ext Pred: Completion of ACD
- 1331.02085: Entry Criteria: Ext Pred: Completion of ACD
- 1331.02090: Entry Criteria: Ext Pred: Completion of ACD
- 1331.02005: Entry Criteria: Ext Pred: Completion of ACD
- 1331.02052: Entry Criteria: Ext Pred: Completion of ACD
- 1331.02068: Entry Criteria: Ext Pred: Completion of ACD / Steps: Change Routing of Vacuum Lines; Aditional Installation
- 1331.02010: Entry Criteria: Ext Pred: Completion of ACD
- 1331.02066: Entry Criteria: Ext Pred: Completion of ACD

| ID | WBS | Activity | Duration | Start | Finish | Predecessors | Total float | Free float | Calendar | Resources | Cost | RESP - Responsibility | STRT%COMP for CM EVM | FNSH%COMP for CM EVM | CAM RESPONSIBLE | CR 13-014 | ReBaseline Actuals Adjustment | Advance Purchase Plan > 500K | CR 08-016 | 12 GEV MAJOR PROCUREMENT CATAGORY | CR 09-012 | CR 11-001 | CR 13-003 | Original Activity ID Rebaseline | Over Under Fixed | EVMS Reporting Codes | BOE Procurement | BOE Labor | BOE Expenses | BOE Adder | CR 13-015 | Post Rebaseline | Obligated Prior to Rebaseline |
| --- | --- | --- | --- | --- | --- | --- | --- | --- | --- | --- | --- | --- | --- | --- | --- | --- | --- | --- | --- | --- | --- | --- | --- | --- | --- | --- | --- | --- | --- | --- | --- | --- | --- |
|  | 03 | **1.3.3.1.03 OIL REMOVAL SKIDS** |  | 2011-01-05 | 2013-08-30 |  |  |  |  |  |  |  |  |  |  |  |  |  |  |  |  |  |  |  |  |  |  |  |  |  |  |  |  |
| 1331.03000 |  | Fab Oil Removl Skids | 115d | 2011-01-05 | 2011-06-17 | 32-03M, 9-110M FS+60d | 113d | 73d |  | MECH TECH [400 h]; ELEC ENG [40 h]; ELEC TECH [120 h]; PROCUREMENT<$50K 60; PROCUREMENT>$50K 69; MECH DES [40 h]; MECH ENG [40 h] | 429,584.95 | ARENIUS D | 1 | 1 | DANA A |  |  |  |  |  |  |  |  |  |  |  |  |  |  |  |  |  |  |
| 1331.03005 |  | Re-Baseline Actuals Adjustment | 1d | 2013-08-30 | 2013-08-30 | 9-130M FS+227d | 20d |  |  | PROCUREMENT>$50K 69 NO ESCALATION | -67,258.9 | ARENIUS D | 1 | 1 | DANA A | 13-014 | ADJ |  |  |  |  |  |  |  |  |  |  |  |  |  |  |  |  |
|  | 04 | **1.3.3.1.04 I & C** |  |  |  |  |  |  |  |  |  |  |  |  |  |  |  |  |  |  |  |  |  |  |  |  |  |  |  |  |  |  |  |
|  | 05 | **1.3.3.1.05 Not Used** |  |  |  |  |  |  |  |  |  |  |  |  |  |  |  |  |  |  |  |  |  |  |  |  |  |  |  |  |  |  |  |
|  | 06 | **1.3.3.1.06 CHL GAS MANAGEMENT RACK** |  | 2011-01-05 | 2013-08-30 |  |  |  |  |  |  |  |  |  |  |  |  |  |  |  |  |  |  |  |  |  |  |  |  |  |  |  |  |
| 1331.06000 |  | Fab CHL Gas Mngmnt Rack | 90d | 2011-01-05 | 2011-05-12 | 9-110M FS+60d | 138d | 98d |  | MECH ENG [40 h]; PROCUREMENT<$50K 60; ELEC TECH [240 h]; SUPPLIES & MATERIALS; ELEC ENG [40 h]; MECH TECH [600 h]; MECH DES [40 h] | 152,683.69 | ARENIUS D | 1 | 1 | DANA A |  |  |  |  |  |  |  |  |  |  |  |  |  |  |  |  |  |  |
| 1331.06005 |  | Re-Baseline Actuals Adjustment | 1d | 2013-08-30 | 2013-08-30 | 9-130M FS+227d | 20d |  |  | PROCUREMENT>$50K 69 NO ESCALATION | 52,367.6 | ARENIUS D | 1 | 1 | DANA A | 13-014 | ADJ |  |  |  |  |  |  |  |  |  |  |  |  |  |  |  |  |
|  | 07 | **1.3.3.1.07 CHL SYSTEM INSTRUMENTATION & CONTROL** |  | 2010-01-05 | 2013-08-30 |  |  |  |  |  |  |  |  |  |  |  |  |  |  |  |  |  |  |  |  |  |  |  |  |  |  |  |  |
| 1331.07000 |  | Fab & Install CHL Instrmenttn & Controls Labor FY10 | 188d | 2010-01-05 | 2010-09-30 | 12131.07015, 9-100M FS+60d, 12131.07015b | 51d | 0d |  | SUPPLIES & MATERIALS; MECH ENG [141.55 h]; MECH TECH [141.55 h]; ELEC ENG [283.11 h]; ELEC TECH [2724.89 h] | 167,522.02 | ARENIUS D | 1 | 1 | DANA A |  |  | APP | 08-016 | 3317 | 09-012 | 11-001 |  |  |  |  |  |  |  |  |  |  |  |
| 1331.07000b |  | Fab & Install CHL Instrmenttn & Controls Procurement | 425d | 2010-01-05 | 2011-09-15 | 12131.07015, 12131.07015b, 9-100M FS+60d | 51d | 11d |  | PROCUREMENT<$50K 60 NO ESCALATION FY11 | 576,862.28 | ARENIUS D | 1 | 1 | DANA A |  |  | APP | 08-016 | 3317 | 09-012 | 11-001 |  |  |  |  |  |  |  |  |  |  |  |
| 1331.07000a |  | Fab & Install CHL Instrmenttn & Controls Labor FY11 | 237d | 2010-10-01 | 2011-09-15 | 1331.07000 | 51d | 11d |  | MECH ENG [178.45 h]; MECH TECH [178.45 h]; ELEC ENG [356.89 h]; ELEC TECH [3435.11 h]; SUPPLIES & MATERIALS | 217,912.39 | ARENIUS D | 1 | 1 | DANA A |  |  | APP | 08-016 | 3317 | 09-012 | 11-001 |  |  |  |  |  |  |  |  |  |  |  |
| 1331.07005 |  | Re-Baseline Actuals Adjustment | 1d | 2013-08-30 | 2013-08-30 | 9-130M FS+227d | 20d |  |  | PROCUREMENT>$50K 69 NO ESCALATION | -33,687.42 | ARENIUS D | 1 | 1 | DANA A | 13-014 | ADJ |  |  |  |  |  |  |  |  |  |  |  |  |  |  |  |  |
|  | 08 | **1.3.3.1.08 INSTRUMENT AIR & SUPPORT EQUIPMENT** |  | 2011-01-05 | 2013-08-30 |  |  |  |  |  |  |  |  |  |  |  |  |  |  |  |  |  |  |  |  |  |  |  |  |  |  |  |  |
| 1331.08000 |  | Proc & Install CHL Instrument Air Sys | 175d | 2011-01-05 | 2011-09-13 | 9-110M FS+60d, 12131.08000 | 53d | 13d |  | MECH DES [200 h]; ELEC ENG [120 h]; PROCUREMENT<$50K 60; ELEC TECH [240 h]; MECH ENG [120 h]; MECH TECH [560 h] | 99,695.85 | ARENIUS D | 1 | 1 | DANA A |  |  |  |  |  |  |  |  |  |  |  |  |  |  |  |  |  |  |
| 1331.08005 |  | Re-Baseline Actuals Adjustment | 1d | 2013-08-30 | 2013-08-30 | 9-130M FS+227d | 20d |  |  | PROCUREMENT>$50K 69 NO ESCALATION | -30,541.46 | ARENIUS D | 1 | 1 | DANA A | 13-014 | ADJ |  |  |  |  |  |  |  |  |  |  |  |  |  |  |  |  |
|  | 09 | **1.3.3.1.09 MOTOR CONTROL CENTERS** |  | 2010-01-05 | 2013-08-30 |  |  |  |  |  |  |  |  |  |  |  |  |  |  |  |  |  |  |  |  |  |  |  |  |  |  |  |  |
| 1331.09000 |  | Proc & Install Motor Control Centers | 150d | 2010-01-05 | 2010-08-06 | 9-100M FS+60d, 12131.09000 | 266d | 226d |  | PROCUREMENT>$50K 69; ELEC ENG [80 h]; PROCUREMENT<$50K 60; ELEC DES [80 h]; SKLLD TRADE [360 h] | 254,449.27 | ARENIUS D | 1 | 1 | DANA A |  |  |  |  |  |  |  |  |  |  |  |  |  |  |  |  |  |  |
| 1331.09005 |  | Re-Baseline Actuals Adjustment | 1d | 2013-08-30 | 2013-08-30 | 9-130M FS+227d | 20d |  |  | PROCUREMENT>$50K 69 NO ESCALATION | -16,549.16 | ARENIUS D | 1 | 1 | DANA A | 13-014 | ADJ |  |  |  |  |  |  |  |  |  |  |  |  |  |  |  |  |
|  | 10 | **1.3.3.1.10 CHL INSTALLATION & DESIGN** |  | 2009-12-09 | 2013-09-30 |  |  |  |  |  |  |  |  |  |  |  |  |  |  |  |  |  |  |  |  |  |  |  |  |  |  |  |  |
| 1331.10000 |  | Proc & Install CHL Piping & Compnts Labor FY10 | 201d | 2009-12-09 | 2010-09-30 | 12131.04025, 12131.10010, 2-15M FS-60d | 144d | 0d |  | MECH DES [186.43 h]; SR STAFF [1491.48 h]; MECH TECH [4054.96 h]; ELEC ENG [652.52 h]; ELEC DES [93.22 h]; ELEC TECH [1211.83 h] | 433,859.19 | ARENIUS D | 1 | 1 | DANA A |  |  |  | 08-016 |  | 09-012 | 11-001 |  |  |  |  |  |  |  |  |  |  |  |
| 1331.1000b |  | Proc & Install CHL Piping & Compnts Procurement | 345d | 2009-12-09 | 2011-05-04 | 12131.04025, 2-15M FS-60d, 12131.10010 | 144d | 104d |  | PROCUREMENT<$50K 60 NO ESCALATION FY11; PROCUREMENT>$50K 69 NO ESCALATION FY11 | 465,884.97 | ARENIUS D | 1 | 1 | DANA A |  |  |  | 08-016 |  | 09-012 | 11-001 |  |  |  |  |  |  |  |  |  |  |  |
| 1331.1000a |  | Proc & Install CHL Piping & Compnts Labor FY11 | 144d | 2010-10-01 | 2011-05-04 | 1331.10000 | 144d | 104d |  | ELEC TECH [868.17 h]; MECH DES [133.57 h]; MECH TECH [2905.04 h]; SR STAFF [1068.52 h]; ELEC ENG [467.48 h]; ELEC DES [66.78 h] | 320,735.54 | ARENIUS D | 1 | 1 | DANA A |  |  |  | 08-016 |  | 09-012 | 11-001 |  |  |  |  |  |  |  |  |  |  |  |
| 1331.1005 |  | Install CHL Cold Box Transfer Line to Linac Labor | 78d | 2013-01-07 | 2013-04-26 | 1331.1000a, 9-130M FS+62d | 151d | 117d |  | PLABOR | 100,000 | ARENIUS D | 1 | 1 | DANA A |  |  |  | 08-016 |  | 09-012 | 11-001 | 13-003 |  |  |  |  |  |  |  |  |  |  |
| 1331.1010 |  | Re-Baseline Actuals Adjustment | 1d | 2013-08-30 | 2013-08-30 | 9-130M FS+227d | 20d |  |  | PROCUREMENT>$50K 69 NO ESCALATION | 1,664,342.45 | ARENIUS D | 1 | 1 | DANA A | 13-014 | ADJ |  |  |  |  |  |  |  |  |  |  |  |  |  |  |  |  |
| 2331.1005 |  | Install CHL Cold Box Transfer Line to Linac Labor | 20d | 2013-09-03 | 2013-09-30 | 9-130M FS+228d | 43d | 9d | 8/5 M-F w/JLAB Holidays ReBaseline | PLABOR; PROCUREMENT<$50K 60 | 4,799.8 | ARENIUS D | 1 | 1 | DANA A |  |  |  | 08-016 |  | 09-012 | 11-001 | 13-003 | 2331.1005 | y | H | PE | PE | PE | NO | 13-015 | PR | OB |

Notes:
- 1331.03000: Entry Criteria: Ext Pred: 1.2.1.3.1.5
- 1331.06000: Entry Criteria: Ext Pred: / 1.2.1.3.1.6
- 1331.10000: Entry Criteria: Ext Pred: Building / BOD
- 1331.1000b: Entry Criteria: Ext Pred: Building / BOD
- 1331.1000a: Entry Criteria: Ext Pred: Building / BOD
- 1331.1005: Entry Criteria: Ext Pred: Building / BOD
- 2331.1005: Entry Criteria: Ext Pred: Building / BOD

| ID | WBS | Activity | Duration | Start | Finish | Predecessors | Total float | Free float | Resources | Cost | RESP - Responsibility | STRT%COMP for CM EVM | FNSH%COMP for CM EVM | Advance Purchase Plan > 500K | CAM RESPONSIBLE | 12 GEV MAJOR PROCUREMENT CATAGORY | CR 12-018 | CR 12-029 | CR 12-032 | CR 13-014 | ReBaseline Actuals Adjustment | CR 11-036 | CR 13-003 | CR 11-004 | CR 10-029 | CR 11-006 |
| --- | --- | --- | --- | --- | --- | --- | --- | --- | --- | --- | --- | --- | --- | --- | --- | --- | --- | --- | --- | --- | --- | --- | --- | --- | --- | --- |
|  | 11 | **1.3.3.1.11 CHL COMMISSIONING** |  | 2011-10-03 | 2013-08-30 |  |  |  |  |  |  |  |  |  |  |  |  |  |  |  |  |  |  |  |  |  |
| 1331.11000 |  | Cmmssn CHL Helium Plant Original | 141d | 2011-10-03 | 2012-04-30 | 1621025, 3A-04M | 146d | 0d | MECH TECH [902.4 h]; ELEC ENG [902.4 h]; ELEC TECH [902.4 h]; MECH ENG [1353.6 h] | 238,513.34 | ARENIUS D | 1 | 1 | APP | DANA A | 33111 | 12-018F | 12-029F | 12-032 |  |  |  |  |  |  |  |
| 1331.11005 |  | Re-Baseline Actuals Adjustment | 1d | 2013-08-30 | 2013-08-30 | 9-130M FS+227d | 20d |  | PROCUREMENT>$50K 69 NO ESCALATION | -72,267.46 | ARENIUS D | 1 | 1 |  | DANA A |  |  |  |  | 13-014 | ADJ |  |  |  |  |  |
|  | 12 | **1.3.3.1.12 LINAC TRANSFER LINE** |  | 2011-01-05 | 2013-08-30 |  |  |  |  |  |  |  |  |  |  |  |  |  |  |  |  |  |  |  |  |  |
| 1331.12000 |  | Fab Cold Box Transfer Line & U-Tubes | 175d | 2011-01-05 | 2011-09-13 | 1331.02010 FS-550d, 1331.02001, 1331.02000, 9-110M FS+60d | 53d | 13d | MECH ENG [80 h]; MECH DES [40 h]; MECH TECH [1320 h]; ELEC ENG [80 h]; ELEC TECH [240 h]; PROCUREMENT<$50K 60; SUPPLIES & MATERIALS | 516,621.98 | ARENIUS D | 1 | 1 |  | DANA A |  |  |  |  |  |  |  |  |  |  |  |
| 1331.12005 |  | Re-Baseline Actuals Adjustment | 1d | 2013-08-30 | 2013-08-30 | 9-130M FS+227d | 20d |  | PROCUREMENT>$50K 69 NO ESCALATION | 244,786.39 | ARENIUS D | 1 | 1 |  | DANA A |  |  |  |  | 13-014 | ADJ |  |  |  |  |  |
|  | 2 | **1.3.3.2 HALL D** |  | 2010-01-05 | 2013-08-30 |  |  |  |  |  |  |  |  |  |  |  |  |  |  |  |  |  |  |  |  |  |
|  | 1 | **1.3.3.2.1 CHL-HALL D TRANSFER LINE AND HEADER** |  | 2011-08-01 | 2013-08-30 |  |  |  |  |  |  |  |  |  |  |  |  |  |  |  |  |  |  |  |  |  |
| 13321015 |  | Eng Design Cryogenic Transfer Line FY11 | 44d | 2011-08-01 | 2011-09-30 | 1562149, 9-110M FS+204d | 90d | 0d | SR STAFF [63.42 h]; ELEC DES [15.86 h]; MECH DES [317.12 h]; OFFICE [63.42 h]; PLABOR; ELEC ENG [47.57 h]; MECH ENG [285.41 h] | 65,953.21 | ARENIUS D | 1 | 1 |  | DANA A |  |  |  |  |  |  | 11-036 |  |  |  |  |
| 13321055 |  | Design Solenoid Distribution Can (Header) BIA | 111d | 2011-08-01 | 2012-01-13 | 9-110M FS+204d | 50d | 42d |  |  | ARENIUS D | 1 | 1 |  | DANA A |  |  |  |  |  |  | 11-036 |  |  |  |  |
| 13321025 |  | Fabricate Cryogenic Transfer Line Labor FY11 | 15d | 2011-09-12 | 2011-09-30 | 13321020 FS-82d | 90d | 0d | MECH ENG [19.51 h]; SR STAFF [9.76 h]; MECH DES [9.76 h]; ELEC TECH [29.27 h]; SUPPLIES & MATERIALS; MECH TECH [263.41 h]; ELEC ENG [4.88 h] | 17,731.98 | ARENIUS D | 1 | 1 |  | DANA A |  |  |  |  |  |  | 11-036 |  |  |  |  |
| 13321035 |  | Fabricate Cryogenic Transfer Line Procurement | 135d | 2011-09-12 | 2012-03-30 | 13321030 FS-123d | 90d | 0d | PROCUREMENT<$50K 60 NO ESCALATION FY12; PROCUREMENT>$50K 69 NO ESCALATION FY12 | 109,000 | ARENIUS D | 1 | 1 |  | DANA A |  |  |  |  |  |  | 11-036 |  |  |  |  |
| 13321020 |  | Eng Design Cryogenic Transfer Line FY12 | 67d | 2011-10-03 | 2012-01-13 | 13321015 | 90d | 0d | MECH ENG [434.59 h]; SR STAFF [96.58 h]; ELEC DES [24.14 h]; MECH DES [482.88 h]; OFFICE [96.58 h]; PLABOR; ELEC ENG [72.43 h] | 103,631.86 | ARENIUS D | 1 | 1 |  | DANA A |  |  |  |  |  |  | 11-036 |  |  |  |  |
| 13321030 |  | Fabricate Cryogenic Transfer Line Labor FY12 | 108d | 2011-10-03 | 2012-03-14 | 13321025 | 90d | 0d | ELEC ENG [35.12 h]; MECH ENG [140.49 h]; SR STAFF [70.24 h]; MECH DES [70.24 h]; ELEC TECH [210.73 h]; MECH TECH [1896.59 h]; SUPPLIES & MATERIALS | 131,730.72 | ARENIUS D | 1 | 1 |  | DANA A |  |  |  |  |  |  | 11-036 |  |  |  |  |
| 13321040 |  | Install Cryogenic Transfer Line Labor | 45d | 2012-03-15 | 2012-05-16 | 13321030, 13321035 FS-12d | 104d | 14d | ELEC TECH [200 h]; MECH TECH [960 h]; SUPPLIES & MATERIALS; ELEC DES [40 h]; ELEC ENG [80 h]; MECH ENG [240 h]; SR STAFF [160 h]; MECH DES [120 h] | 127,704.1 | ARENIUS D | 1 | 1 |  | DANA A |  |  |  |  |  |  | 11-036 |  |  |  |  |
| 13321045 |  | Install Cryogenic Transfer Line Procurement | 55d | 2012-03-15 | 2012-05-31 | 13321030, 13321035 FS-12d | 90d | 0d | PROCUREMENT<$50K 60 | 27,861.3 | ARENIUS D | 1 | 1 |  | DANA A |  |  |  |  |  |  | 11-036 |  |  |  |  |
| 13321060 |  | Fabricate Solenoid Distribution Can (Header) Labor | 84d | 2012-03-16 | 2012-07-13 | 13321055, 9-120M FS+109d | 8d | 0d | ELEC DES [280 h]; PLABOR; ELEC ENG [520 h]; MECH ENG [960 h]; SR STAFF [80 h]; MECH DES [800 h]; SUPPLIES & MATERIALS | 350,228.92 | ARENIUS D | 1 | 1 |  | DANA A |  |  |  |  |  |  | 11-036 |  |  |  |  |
| 13321065 |  | Fabricate Solenoid Distribution Can (Header) Procurement | 96d | 2012-03-16 | 2012-07-31 | 13321060 FS-84d | 8d | 0d | PROCUREMENT<$50K 60; PROCUREMENT>$50K 69 | 175,423 | ARENIUS D | 1 | 1 |  | DANA A |  |  |  |  |  |  | 11-036 |  |  |  |  |
| 13321050 |  | Commission Cryogenic Transfer Line | 18d | 2012-06-08 | 2012-07-03 | 13321042 FS-128d, 13321040, 13321045 FS+4d | 90d | 62d | SUPPLIES & MATERIALS; ELEC ENG [40 h]; MECH ENG [120 h]; SR STAFF [40 h]; MECH DES [80 h]; ELEC TECH [80 h]; MECH TECH [360 h] | 43,266.8 | ARENIUS D | 1 | 1 |  | DANA A |  |  |  |  |  |  | 11-036 |  |  |  |  |
| 13321070 |  | Install Solenoid Distribution Can (Header) | 54d | 2012-07-16 | 2012-09-28 | 151155, 13321065 FS-12d | 8d | 0d | SR STAFF [80 h]; ELEC DES [240 h]; ELEC ENG [80 h]; MECH DES [120 h]; MECH ENG [720 h] | 83,074 | ARENIUS D | 1 | 1 |  | DANA A |  |  |  |  |  |  | 11-036 |  |  |  |  |
| 13321042 |  | Install Hall D Solenoid External Warm/Vent Piping Labor | 20d | 2012-11-08 | 2012-12-07 | 13321040, 9-130M FS+28d | 90d | 0d | ELEC TECH [200 h]; MECH TECH [960 h]; SUPPLIES & MATERIALS; ELEC DES [40 h]; ELEC ENG [80 h]; MECH ENG [240 h]; SR STAFF [160 h]; MECH DES [120 h] | 130,892.1 | ARENIUS D | 1 | 1 |  | DANA A |  |  |  |  |  |  |  | 13-003 |  |  |  |
| 13321075 |  | Re-Baseline Actuals Adjustment | 1d | 2013-08-30 | 2013-08-30 | 9-130M FS+227d | 20d |  | PROCUREMENT>$50K 69 NO ESCALATION | -247,899.6 | ARENIUS D | 1 | 1 |  | DANA A |  |  |  |  | 13-014 | ADJ |  |  |  |  |  |
|  | 2 | **1.3.3.2.2 HALL D COLD BOX** |  | 2010-01-05 | 2013-08-30 |  |  |  |  |  |  |  |  |  |  |  |  |  |  |  |  |  |  |  |  |  |
| 13322000 |  | Refurblish H-D Cold Box | 25d | 2010-01-05 | 2010-02-09 | 121322000, 9-100M FS+60d | 448d | 260d | PROCUREMENT<$50K 60; SUPPLIES & MATERIALS; MECH TECH [200 h]; ELEC TECH [160 h] | 65,007.69 | ARENIUS D | 1 | 1 |  | DANA A |  |  |  |  |  |  | 11-036 |  | 11-004 |  |  |
| 13322005 |  | Relocation of Helium Refrigerator Labor (Frozen by CR11-036) | 41d | 2011-06-02 | 2011-07-29 | 9-110M FS+163d | 44d |  | ELEC TECH [437.33 h]; MECH TECH [583.11 h]; ELEC ENG [291.56 h]; MECH ENG [510.22 h]; PLABOR; SR STAFF [109.33 h]; SUPPLIES & MATERIALS | 134,842.76 | ARENIUS D | 1 | 1 |  | DANA A |  |  |  |  |  |  | 11-036 |  | 11-004 | 10-029 | 11-006 |
| 13322006 |  | Reverse entry per CR11-036 | 5d | 2011-08-01 | 2011-08-05 | 9-110M FS+204d | 39d |  | MECH TECH [-583.11 h]; ELEC ENG [-291.56 h]; MECH ENG [-510.22 h]; PLABOR; SR STAFF [-109.33 h]; SUPPLIES & MATERIALS; ELEC TECH [-437.33 h] | -134,842.76 | ARENIUS D | 1 | 1 |  | DANA A |  |  |  |  |  |  | 11-036 |  | 11-004 | 10-029 | 11-006 |
| 13322007 |  | Relocation of Helium Refrigerator Labor (Revised by CR11-036) | 79d | 2011-10-03 | 2012-02-01 | 9-120M | 158d | 0d | MECH TECH [640 h]; ELEC ENG [320 h]; MECH ENG [560 h]; PLABOR; SR STAFF [120 h]; SUPPLIES & MATERIALS; ELEC TECH [480 h] | 152,715.66 | ARENIUS D | 1 | 1 |  | DANA A |  |  |  |  |  |  | 11-036 |  | 11-004 | 10-029 | 11-006 |
| 13322010 |  | Relocation of Helium Refrigerator Procurement | 98d | 2011-10-03 | 2012-02-29 | 9-120M | 158d | 0d | PROCUREMENT<$50K 60; PROCUREMENT>$50K 69 | 153,333.74 | ARENIUS D | 1 | 1 |  | DANA A |  |  |  |  |  |  | 11-036 |  | 11-004 | 10-029 | 11-006 |
| 13322015 |  | Re-Baseline Actuals Adjustment | 1d | 2013-08-30 | 2013-08-30 | 9-130M FS+227d | 20d |  | PROCUREMENT>$50K 69 NO ESCALATION | -185,714.51 | ARENIUS D | 1 | 1 |  | DANA A |  |  |  |  | 13-014 | ADJ |  |  |  |  |  |

Notes:
- 1331.11000: Entry Criteria: Ext Pred: Building / BOD

| ID | WBS | Activity | Duration | Start | Finish | Predecessors | Total float | Free float | Resources | Cost | RESP - Responsibility | STRT%COMP for CM EVM | FNSH%COMP for CM EVM | CAM RESPONSIBLE | CR 10-059 | CR 11-004 | CR 11-036 | CR 12-001 | CR 13-014 | ReBaseline Actuals Adjustment | CR 08-016 | CR 09-012 | Profile change | 12 GeV 2nd level Critical Path |
| --- | --- | --- | --- | --- | --- | --- | --- | --- | --- | --- | --- | --- | --- | --- | --- | --- | --- | --- | --- | --- | --- | --- | --- | --- |
|  | 3 | **1.3.3.2.3 HALL DISTRIBUTION SYSTEM** |  | 2011-03-01 | 2013-08-30 |  |  |  |  |  |  |  |  |  |  |  |  |  |  |  |  |  |  |  |
| 13323000 |  | Proc H-D Refrigerator Equip & Piping Proc | 249d | 2011-03-01 | 2012-02-29 | 16332040F, 13322000, 121323000 | 209d | 67d | PROCUREMENT<$50K 60 NO ESCALATION FY12; PROCUREMENT>$50K 69 NO ESCALATION FY12 | 300,048.74 | ARENIUS D | 1 | 1 | DANA A | 10-059 | 11-004 | 11-036 |  |  |  |  |  |  |  |
| 13323005 |  | Proc & Install H-D Refrigerator Equip & Piping (Original labor Frozen per CR 11-036) | 107d | 2011-03-01 | 2011-07-29 | 121323000, 16332040F, 13322000 | 188d | 23d | ELEC ENG [98.77 h]; ELEC DES [98.77 h]; ELEC TECH [65.85 h]; SUPPLIES & MATERIALS; MECH ENG [98.77 h]; MECH DES [65.85 h]; MECH TECH [1415.69 h] | 89,111.73 | ARENIUS D | 1 | 1 | DANA A | 10-059 | 11-004 | 11-036 |  |  |  |  |  |  |  |
| 13323010 |  | Reverse Entry per CR 11-036) | 5d | 2011-08-01 | 2011-08-05 | 9-110M FS+204d | 39d |  | SUPPLIES & MATERIALS; MECH ENG [-98.77 h]; MECH DES [-65.85 h]; MECH TECH [-1415.69 h]; ELEC ENG [-98.77 h]; ELEC DES [-98.77 h]; ELEC TECH [-65.85 h] | -89,111.73 | ARENIUS D | 1 | 1 | DANA A | 10-059 | 11-004 | 11-036 |  |  |  |  |  |  |  |
| 13323015 |  | Install H-D Refrigerator Equip & Piping Labor (Revised per CR 11-036) FY11 | 21d | 2011-09-01 | 2011-09-30 | 9-110M FS+227d | 142d | 0d | ELEC DES [23.55 h]; ELEC TECH [15.7 h]; SUPPLIES & MATERIALS; MECH ENG [23.55 h]; MECH DES [15.7 h]; MECH TECH [337.57 h]; ELEC ENG [23.55 h] | 21,248.15 | ARENIUS D | 1 | 1 | DANA A | 10-059 | 11-004 | 11-036 | 12-001 |  |  |  |  |  |  |
| 13323020 |  | Install H-D Refrigerator Equip & Piping Procurement (Revised per CR 11-036) | 119d | 2011-09-01 | 2012-02-29 | 13323015a FS-107d | 142d | 0d | PROCUREMENT>$50K 69 NO ESCALATION FY12 | 52,694.49 | ARENIUS D | 1 | 1 | DANA A | 10-059 | 11-004 | 11-036 |  |  |  |  |  |  |  |
| 13323015a |  | Install H-D Refrigerator Equip & Piping Labor (Revised per CR 11-036) FY12 | 86d | 2011-10-03 | 2012-02-10 | 13323015 | 142d | 0d | MECH DES [64.3 h]; MECH TECH [1382.43 h]; ELEC ENG [96.45 h]; ELEC DES [96.45 h]; ELEC TECH [64.3 h]; SUPPLIES & MATERIALS; MECH ENG [96.45 h] | 89,788.15 | ARENIUS D | 1 | 1 | DANA A | 10-059 | 11-004 | 11-036 | 12-001 |  |  |  |  |  |  |
| 13323025 |  | Re-Baseline Actuals Adjustment | 1d | 2013-08-30 | 2013-08-30 | 9-130M FS+227d | 20d |  | PROCUREMENT>$50K 69 NO ESCALATION | -201,441.51 | ARENIUS D | 1 | 1 | DANA A |  |  |  |  | 13-014 | ADJ |  |  |  |  |
|  | 4 | **1.3.3.2.4 INSTRUMENTATION & CONTROLS** |  | 2011-05-17 | 2013-08-30 |  |  |  |  |  |  |  |  |  |  |  |  |  |  |  |  |  |  |  |
| 13324000 |  | Install H-D Refrigerator Instrmenttn & Controls Procurement | 216d | 2011-05-17 | 2012-03-30 | 9-110M FS+60d, 121324000, 13326000 FS-52d | 142d | 0d | PROCUREMENT<$50K 60 NO ESCALATION FY12 | 137,074.16 | ARENIUS D | 1 | 1 | DANA A | 10-059 | 11-004 | 11-036 |  |  |  | 08-016 | 09-012 |  |  |
| 13324005 |  | Install H-D Refrigerator Instrmenttn & Controls Original Labor Frozen per CR 11-036 | 52d | 2011-05-17 | 2011-07-29 | 121324000, 9-110M FS+60d, 13326000 FS-52d | 306d | 164d | ELEC TECH [372.21 h]; SUPPLIES & MATERIALS; ELEC ENG [65.68 h] | 23,035.87 | ARENIUS D | 1 | 1 | DANA A | 10-059 | 11-004 | 11-036 |  |  |  | 08-016 | 09-012 |  |  |
| 13324010 |  | Reverse Entry Per CR 11-036 | 5d | 2011-08-01 | 2011-08-05 | 9-110M FS+204d | 39d |  | ELEC TECH [-372.21 h]; SUPPLIES & MATERIALS; ELEC ENG [-65.68 h] | -23,035.87 | ARENIUS D | 1 | 1 | DANA A | 10-059 | 11-004 | 11-036 |  |  |  | 08-016 | 09-012 |  |  |
| 13324015 |  | Install H-D Refrigerator Instrmenttn & Controls FY11 | 21d | 2011-09-01 | 2011-09-30 | 13326010 FS-125d, 121324000, 9-110M FS+227d, 13326015 FS-141d | 158d | 0d | ELEC TECH [114.24 h]; SUPPLIES & MATERIALS; ELEC ENG [20.16 h] | 7,070.33 | ARENIUS D | 1 | 1 | DANA A | 10-059 | 11-004 | 11-036 | 12-001 |  |  | 08-016 | 09-012 |  |  |
| 13324015a |  | Install H-D Refrigerator Instrmenttn & Controls FY12 | 104d | 2011-10-03 | 2012-03-08 | 13324015 | 158d | 16d | ELEC TECH [565.76 h]; SUPPLIES & MATERIALS; ELEC ENG [99.84 h] | 36,129.37 | ARENIUS D | 1 | 1 | DANA A | 10-059 | 11-004 | 11-036 | 12-001 |  |  | 08-016 | 09-012 |  |  |
| 13324020 |  | Re-Baseline Actuals Adjustment | 1d | 2013-08-30 | 2013-08-30 | 9-130M FS+227d | 20d |  | PROCUREMENT>$50K 69 NO ESCALATION | 277,907.69 | ARENIUS D | 1 | 1 | DANA A |  |  |  |  | 13-014 | ADJ |  |  |  |  |
|  | 5 | **1.3.3.2.5 U-TUBES** |  | 2011-07-07 | 2013-08-30 |  |  |  |  |  |  |  |  |  |  |  |  |  |  |  |  |  |  |  |
| 13325000 |  | Fab Cryogenic U-Tubes (Frozen Per CR 11-036) | 17d | 2011-07-07 | 2011-07-29 | 13323005 FS-40d, 121325000, 9-110M FS+125d, 13323015a FS-155d, 13323020 FS-159d | 165d | 23d | SUPPLIES & MATERIALS; MECH TECH [255 h] | 12,004.44 | ARENIUS D | 1 | 1 | DANA A | 10-059 | 11-004 | 11-036 |  |  |  |  |  | C |  |
| 13325005 |  | Reverse Entry Per CR 11-036 | 5d | 2011-08-01 | 2011-08-05 | 9-110M FS+204d | 39d |  | SUPPLIES & MATERIALS; MECH TECH [-255 h] | -12,004.44 | ARENIUS D | 1 | 1 | DANA A | 10-059 | 11-004 | 11-036 |  |  |  |  |  | C |  |
| 13325010 |  | Fab Cryogenic U-Tubes Labor (Revised Per CR 11-036) | 40d | 2011-12-08 | 2012-02-10 | 9-110M FS+125d, 13323005 FS-40d, 13323015a FS-40d, 13323020 FS-52d, 121325000, 13323000 FS-119d | 142d | 0d | MECH TECH [600 h]; SUPPLIES & MATERIALS | 29,144.41 | ARENIUS D | 1 | 1 | DANA A | 10-059 | 11-004 | 11-036 |  |  |  |  |  | C |  |
| 13325015 |  | Fab Cryogenic U-Tubes Procurment (Revised Per CR 11-036) | 40d | 2011-12-08 | 2012-02-10 | 121325000, 9-110M FS+125d, 13323000 FS-119d, 13323020 FS-52d, 13323015a FS-40d, 13323005 FS-40d | 142d | 0d | PROCUREMENT<$50K 60 | 26,020.93 | ARENIUS D | 1 | 1 | DANA A | 10-059 | 11-004 | 11-036 |  |  |  |  |  | C |  |
| 13325020 |  | Re-Baseline Actuals Adjustment | 1d | 2013-08-30 | 2013-08-30 | 9-130M FS+227d | 20d |  | PROCUREMENT>$50K 69 NO ESCALATION | -25,704.19 | ARENIUS D | 1 | 1 | DANA A |  |  |  |  | 13-014 | ADJ |  |  |  |  |
|  | 6 | **1.3.3.2.6 FIELD INSTALLATION** |  | 2011-03-22 | 2013-08-30 |  |  |  |  |  |  |  |  |  |  |  |  |  |  |  |  |  |  |  |
| 13326000 |  | Install Field Compnts (Frozen Per CR 11-036) | 92d | 2011-03-22 | 2011-07-29 | 13325015 FS-222d, 13325000 FS-115d, 3C-09M, 9-110M FS+60d, 13325010 FS-222d | 142d | 0d | MECH ENG [122.67 h]; ELEC ENG [122.67 h]; ELEC TECH [552 h]; SUPPLIES & MATERIALS; MECH DES [30.67 h]; SKLLD TRADE [92 h]; MECH TECH [1870.67 h] | 146,483.56 | ARENIUS D | 1 | 1 | DANA A | 10-059 | 11-004 | 11-036 |  |  |  | 08-016 | 09-012 |  | 2 |
| 13326005 |  | Reverse Entry Per CR 11-036 | 5d | 2011-08-01 | 2011-08-05 | 9-110M FS+204d | 39d |  | ELEC ENG [-122.67 h]; ELEC TECH [-552 h]; SUPPLIES & MATERIALS; MECH DES [-30.67 h]; SKLLD TRADE [-92 h]; MECH TECH [-1870.67 h]; MECH ENG [-122.67 h] | -146,483.56 | ARENIUS D | 1 | 1 | DANA A | 10-059 | 11-004 | 11-036 |  |  |  | 08-016 | 09-012 |  | 2 |
| 13326010 |  | Install Field Compnts Labor (Revised Per CR 11-036) | 104d | 2011-10-03 | 2012-03-08 | 13325000 FS-115d, 13322007 FS-79d, 13325010 FS-86d, 13322010 FS-98d, 3C-09M, 9-110M FS+60d, 13325015 FS-86d | 158d | 0d | MECH ENG [160 h]; ELEC ENG [160 h]; ELEC TECH [720 h]; SUPPLIES & MATERIALS; MECH DES [40 h]; SKLLD TRADE [120 h]; MECH TECH [2440 h] | 197,146.44 | ARENIUS D | 1 | 1 | DANA A | 10-059 | 11-004 | 11-036 |  |  |  | 08-016 | 09-012 |  | 2 |
| 13326015 |  | Install Field Compnts Procurement (Revised Per CR 11-036) | 120d | 2011-10-03 | 2012-03-30 | 13325000 FS-115d, 13325015 FS-86d, 9-110M FS+60d, 3C-09M, 13325010 FS-86d | 158d | 0d | PROCUREMENT<$50K 60 | 40,880.01 | ARENIUS D | 1 | 1 | DANA A | 10-059 | 11-004 | 11-036 |  |  |  | 08-016 | 09-012 |  | 2 |
| 13326020 |  | Re-Baseline Actuals Adjustment | 1d | 2013-08-30 | 2013-08-30 | 9-130M FS+227d | 20d |  | PROCUREMENT>$50K 69 NO ESCALATION | 216,504.83 | ARENIUS D | 1 | 1 | DANA A |  |  |  |  | 13-014 | ADJ |  |  |  |  |

Notes:
- 13323000: Entry Criteria: Ext Pred: Building / BOD
- 13323005: Entry Criteria: Ext Pred: Building / BOD
- 13323010: Entry Criteria: Ext Pred: Building / BOD
- 13323015: Entry Criteria: Ext Pred: Building / BOD
- 13323020: Entry Criteria: Ext Pred: Building / BOD
- 13323015a: Entry Criteria: Ext Pred: Building / BOD
- 13324000: Entry Criteria: Ext Pred: Building / BOD
- 13324005: Entry Criteria: Ext Pred: Building / BOD
- 13324010: Entry Criteria: Ext Pred: Building / BOD
- 13324015: Entry Criteria: Ext Pred: Building / BOD
- 13324015a: Entry Criteria: Ext Pred: Building / BOD
- 13326000: Entry Criteria: Ext Pred: Building / BOD
- 13326005: Entry Criteria: Ext Pred: Building / BOD
- 13326010: Entry Criteria: Ext Pred: Building / BOD
- 13326015: Entry Criteria: Ext Pred: Building / BOD

| ID | WBS | Activity | Type | Duration | Start | Finish | Predecessors | Total float | Free float | Resources | Cost | RESP - Responsibility | STRT%COMP for CM EVM | FNSH%COMP for CM EVM | 12 GeV 2nd level Critical Path | CAM RESPONSIBLE | CR 09-012 | CR 10-059 | CR 11-004 | CR 11-036 | CR 13-014 | ReBaseline Actuals Adjustment | CR 08-029 | CR 08-059 | CR 10-065 | CR 11-041 | CR 13-003 | CR 08-058 | Milestone Level | CR 09-047 | Advance Purchase Plan > 500K | CR 08-016 | 12 GEV MAJOR PROCUREMENT CATAGORY | CR 10-001 | CR 07-024 | CR 10-003 | CR 09-034 | CR 11-001 | CR 12-035 | CR 10-030 | CR 12-001 | Inter Project Link (IPL) | CR 11-057 |
| --- | --- | --- | --- | --- | --- | --- | --- | --- | --- | --- | --- | --- | --- | --- | --- | --- | --- | --- | --- | --- | --- | --- | --- | --- | --- | --- | --- | --- | --- | --- | --- | --- | --- | --- | --- | --- | --- | --- | --- | --- | --- | --- | --- |
|  | 7 | **1.3.3.2.7 COMMISSIONING** |  |  | 2012-04-02 | 2013-08-30 |  |  |  |  |  |  |  |  |  |  |  |  |  |  |  |  |  |  |  |  |  |  |  |  |  |  |  |  |  |  |  |  |  |  |  |  |  |
| 13327000 |  | Cmmssn H-D Refrigerator Sys |  | 23d | 2012-04-02 | 2012-05-02 | 16332010U, 13324000, 13326000, 13326010, 13326015 FS-16d, 13324015a, 16332010, 13324005 | 142d | 134d | PROCUREMENT<$50K 60; ELEC DES [120 h]; ELEC ENG [320 h]; SUPPLIES & MATERIALS; MECH DES [120 h] | 81,490.15 | ARENIUS D | 1 | 1 | 2 | DANA A | 09-012 | 10-059 | 11-004 | 11-036 |  |  |  |  |  |  |  |  |  |  |  |  |  |  |  |  |  |  |  |  |  |  |  |
| 13327005 |  | Re-Baseline Actuals Adjustment |  | 1d | 2013-08-30 | 2013-08-30 | 9-130M FS+227d | 20d |  | PROCUREMENT>$50K 69 NO ESCALATION | -59,402.38 | ARENIUS D | 1 | 1 |  | DANA A |  |  |  |  | 13-014 | ADJ |  |  |  |  |  |  |  |  |  |  |  |  |  |  |  |  |  |  |  |  |  |
|  | 4 | **1.3.4 BEAM TRANSPORT** |  |  | 2009-01-02 | 2013-11-18 |  |  |  |  |  |  |  |  |  |  |  |  |  |  |  |  |  |  |  |  |  |  |  |  |  |  |  |  |  |  |  |  |  |  |  |  |  |
|  | 1 | **1.3.4.1 SPREADERS & RECOMBINERS** |  |  | 2009-01-02 | 2013-11-11 |  |  |  |  |  |  |  |  |  |  |  |  |  |  |  |  |  |  |  |  |  |  |  |  |  |  |  |  |  |  |  |  |  |  |  |  |  |
|  | 1 | **1.3.4.1.1 DIPOLES** |  |  | 2009-01-02 | 2013-10-15 |  |  |  |  |  |  |  |  |  |  |  |  |  |  |  |  |  |  |  |  |  |  |  |  |  |  |  |  |  |  |  |  |  |  |  |  |  |
| 13411075 |  | Prcrmnt Prep of Septa (S/R Dipoles) |  | 112d | 2009-01-02 | 2009-06-11 | 9-090M FS+59d | 362d | 0d | MECH ENG [160 h]; MECH DES [60 h] | 12,840 | BEVINS M | 1 | 1 |  | MIKE B |  |  |  |  |  |  | 08-029 | 08-059 | 10-065 | 11-041 | 13-003F |  |  |  |  |  |  |  |  |  |  |  |  |  |  |  |  |
| 13411909LOE |  | FY09 Mngmnt & Oversight (S/R Dipoles) |  | 189d | 2009-01-02 | 2009-09-30 | 13411909LOEXD | 20d | 0d | SR STAFF [396.29 h]; TRAVEL | 62,981.29 | BEVINS M | 1 | 1 |  | MIKE B |  |  |  |  |  |  |  |  |  |  |  | 08-058 |  |  |  |  |  |  |  |  |  |  |  |  |  |  |  |
| 13411095 |  | Prcrmnt Prep of Curved Dipoles (S/R Dipoles) |  | 117d | 2009-01-12 | 2009-06-26 | 9-090M FS+65d | 111d | 0d | MECH ENG [52 h]; MECH DES [44 h] | 5,247.08 | BEVINS M | 1 | 1 |  | MIKE B |  |  |  |  |  |  | 08-029 |  |  |  |  |  |  |  |  |  |  |  |  |  |  |  |  |  |  |  |  |
| 13411115 |  | Prcrmnt Prep for C Dipoles & Coils (S/R Dipoles) |  | 117d | 2009-01-12 | 2009-06-26 | 9-090M FS+65d | 196d | 0d | MECH DES [72 h]; MECH ENG [80 h] | 8,261.28 | BEVINS M | 1 | 1 |  | MIKE B |  |  |  |  |  |  | 08-029 |  |  |  |  |  |  |  |  |  |  |  |  |  |  |  |  |  |  |  |  |
| 13411080M |  | Award Contract for Septa (S/R DIPOLES) | milestone | 0d | 2009-06-12 | 2009-06-12 | 121416010, 13411075, 121411110M FS-34d | 362d | 0d |  |  | BEVINS M | 1 | 1 |  | MIKE B |  |  |  |  |  |  | 08-029 | 08-059 | 10-065 | 11-041 | 13-003F |  | 6 | 09-047 |  |  |  |  |  |  |  |  |  |  |  |  |  |
| 13411085 |  | Vend Fab Septa (S/R Dipoles) LABOR INITIAL FY09 |  | 35d | 2009-06-12 | 2009-07-31 | 13411080M | 362d | 0d | MECH ENG [28 h]; MECH DES [11.6 h] | 2,295.22 | BEVINS M | 1 | 1 |  | MIKE B | 09-012 |  |  |  |  |  | 08-029 | 08-059 | 10-065 | 11-041 | 13-003F |  |  | 09-047 | APP | 08-016 | 3411A |  |  |  |  |  |  |  |  |  |  |
| 13411100M |  | Award Contract for Curved Dipoles (S/R DIPOLES) | milestone | 0d | 2009-06-29 | 2009-06-29 | 13411095, 121411110M FS-24d, 121416010 | 111d | 0d |  |  | BEVINS M | 1 | 1 |  | MIKE B |  |  |  |  |  |  | 08-029 |  |  |  |  |  | 6 |  |  |  |  |  |  |  |  |  |  |  |  |  |  |
| 13411105 |  | P-1 Vend Fab Curved Dipoles (S/R Dipoles) Labor FY09 |  | 66d | 2009-06-29 | 2009-09-30 | 13411100M | 111d | 0d | MECH DES [12.77 h]; MECH ENG [28.74 h] | 2,393.74 | BEVINS M | 1 | 1 |  | MIKE B | 09-012 |  |  |  |  |  | 08-029 |  |  |  |  |  |  |  | APP | 08-016 |  | 10-001B |  |  |  |  |  |  |  |  |  |
| 13411120M |  | Award Contract for C Dipoles & Coils (S/R DIPOLES) | milestone | 0d | 2009-06-29 | 2009-06-29 | 121416010 FS-20d, 13411115 | 196d | 0d |  |  | BEVINS M | 1 | 1 |  | MIKE B |  |  |  |  |  |  | 08-029 |  |  |  |  |  | 6 |  |  |  |  |  |  |  |  |  |  |  |  |  |  |
| 13411125 |  | P-1 Vend Fab C Dipoles & Coils (S/R Dipoles) Labor FY09 |  | 66d | 2009-06-29 | 2009-09-30 | 13411120M | 196d | 0d | MECH DES [23.42 h]; MECH ENG [55.35 h] | 4,558.61 | BEVINS M | 1 | 1 |  | MIKE B | 09-012 |  |  |  |  |  | 08-029 |  |  |  |  |  |  |  | APP | 08-016 | 3411B | 10-001B | 07-024 |  |  |  |  |  |  |  |  |
| 13411086 |  | Vend Fab Septa (S/R Dipoles) LABOR FINAL FY09 |  | 42d | 2009-08-03 | 2009-09-30 | 13411085 | 362d | 0d | MECH ENG [67.2 h]; MECH DES [23.2 h] | 5,305.12 | BEVINS M | 1 | 1 |  | MIKE B | 09-012 |  |  |  |  |  | 08-029 | 08-059 | 10-065 | 11-041 | 13-003F |  |  | 09-047 | APP | 08-016 | 3411A |  |  |  |  |  |  |  |  |  |  |
| 13411087 |  | Vend Fab Septa (S/R Dipoles) Materials |  | 36d | 2009-08-26 | 2009-10-15 | 9-090M FS+223d | 764d | 114d | PROCUREMENT>$50K 69 NO ESCALATION; PROCUREMENT<$50K 60 NO ESCALATION | 202,000 | BEVINS M | 1 | 1 |  | MIKE B |  |  |  |  |  |  |  |  | 10-065 | 11-041 | 13-003F |  |  | 09-047 | APP |  | 3411A | 10-001A |  |  |  |  |  |  |  |  |  |
| 13411087A |  | Vend Fab Septa (S/R Dipoles) First Article ZA Magnet |  | 105d | 2009-08-26 | 2010-02-02 | 9-090M FS+223d | 468d | 456d | PROCUREMENT>$50K 69 NO ESCALATION | 39,900 | BEVINS M | 1 | 1 |  | MIKE B |  |  |  |  |  |  |  |  | 10-065 | 11-041 |  |  |  | 09-047 | APP |  | 3411A | 10-001A |  |  |  |  |  |  |  |  |  |
| 13411087B |  | Vend Fab Septa (S/R Dipoles) Deliver (4) ZA Magnet Assemblies |  | 393d | 2009-08-26 | 2011-03-31 | 9-090M FS+223d | 407d | 395d | PROCUREMENT>$50K 69 NO ESCALATION | 159,600 | BEVINS M | 1 | 1 |  | MIKE B |  |  |  |  |  |  |  |  | 10-065 | 11-041 | 13-003F |  |  | 09-047 | APP |  | 3411A | 10-001A |  |  |  |  |  |  |  |  |  |
| 13411087C |  | Vend Fab Septa (S/R Dipoles) Deliver (3) ZA Magnet Assemblies |  | 477d | 2009-08-26 | 2011-07-29 | 9-090M FS+223d | 323d | 311d | PROCUREMENT>$50K 69 NO ESCALATION | 150,000 | BEVINS M | 1 | 1 |  | MIKE B |  |  |  |  |  |  |  |  | 10-065 | 11-041 | 13-003F |  |  | 09-047 | APP |  | 3411A | 10-001A |  |  |  |  |  |  |  |  |  |
| 13411087D |  | Vend Fab Septa (S/R Dipoles) Deliver ZA Spare Coil Set (Frozen by CR 11-041) |  | 477d | 2009-08-26 | 2011-07-29 | 9-090M FS+223d | 323d | 311d | PROCUREMENT>$50K 69 NO ESCALATION | 23,800 | BEVINS M | 1 | 1 |  | MIKE B |  |  |  |  |  |  |  |  | 10-065 | 11-041 | 13-003F |  |  | 09-047 | APP |  | 3411A | 10-001A |  |  |  |  |  |  |  |  |  |
| 13411087D10 |  | Vend Fab Septa (S/R Dipoles) Deliver (2) YA Magnet Assemblies (Frozen by CR 11-041) |  | 562d | 2009-08-26 | 2011-11-30 | 9-090M FS+223d | 238d | 0d | PROCUREMENT>$50K 69 NO ESCALATION | 68,850 | BEVINS M | 1 | 1 |  | MIKE B |  |  |  |  |  |  |  |  | 10-065 | 11-041 | 13-003F |  |  | 09-047 | APP |  | 3411A | 10-001A |  |  |  |  |  |  |  |  |  |
| 13411087D5 |  | Vend Fab Septa (S/R Dipoles) Deliver (2) ZB Coil Sets (Frozen by CR 11-041) |  | 579d | 2009-08-26 | 2011-12-30 | 9-090M FS+223d | 221d | 209d | PROCUREMENT>$50K 69 NO ESCALATION | 51,000 | BEVINS M | 1 | 1 |  | MIKE B |  |  |  |  |  |  |  |  | 10-065 | 11-041 | 13-003F |  |  | 09-047 | APP |  | 3411A | 10-001A |  |  |  |  |  |  |  |  |  |
| 13411086ALOE |  | Vend Fab Septa (S/R Dipoles) LABOR FY10 |  | 248d | 2009-10-01 | 2010-09-30 | 13411086 | 362d | 0d | MECH DES [135.6 h]; MECH ENG [397.2 h] | 32,290.16 | BEVINS M | 1 | 1 |  | MIKE B | 09-012 |  |  |  |  |  | 08-029 | 08-059 | 10-065 | 11-041 | 13-003F |  |  | 09-047 | APP | 08-016 | 3411A |  |  |  |  |  |  |  |  |  |  |
| 13411105b |  | P-1 Vend Fab Curved Dipoles (S/R Dipoles) Labor FY10 |  | 182d | 2009-10-01 | 2010-06-28 | 13411105 | 111d | 0d | MECH DES [35.23 h]; MECH ENG [79.26 h] | 6,813.08 | BEVINS M | 1 | 1 |  | MIKE B |  |  |  |  |  |  |  |  |  |  |  |  |  |  | APP |  |  | 10-001B |  |  |  |  |  |  |  |  |  |
| 13411125b |  | P-1 Vend Fab C Dipoles & Coils (S/R Dipoles) Labor FY10 |  | 182d | 2009-10-01 | 2010-06-28 | 13411125 | 196d | 0d | MECH DES [64.58 h]; MECH ENG [152.65 h] | 12,973.6 | BEVINS M | 1 | 1 |  | MIKE B |  |  |  |  |  |  |  |  |  |  |  |  |  |  | APP |  | 3411B | 10-001B |  |  |  |  |  |  |  |  |  |
| 13411910LOE |  | FY10 Mngmnt & Oversight (S/R Dipoles) |  | 248d | 2009-10-01 | 2010-09-30 | 121411909LOE, 13411909LOE | 20d | 0d | SR STAFF [520 h]; TRAVEL | 85,344.06 | BEVINS M | 1 | 1 |  | MIKE B |  |  |  |  |  |  |  |  |  |  |  |  |  |  |  |  |  |  |  |  |  |  |  |  |  |  |  |
| 13411055 |  | Prcrmnt Prep for H Steel (S/R Dipoles) |  | 110d | 2009-10-05 | 2010-03-19 | 9-100M FS+2d | 169d | 0d | MECH ENG [80 h]; MECH DES [60 h] | 7,982.4 | BEVINS M | 1 | 1 |  | MIKE B |  |  |  |  |  |  | 08-029 |  |  |  |  |  |  |  |  |  |  |  |  |  |  |  |  |  |  |  |  |
| 13411105c |  | Vend Fab Curved Dipoles Peg Point #1 Receipt of Coil Materials and Tooling |  | 63d | 2009-11-18 | 2010-02-26 | 13411100M, 9-100M FS+34d | 46d | 0d | PROCUREMENT<$50K 60 NO ESCALATION; PROCUREMENT>$50K 69 NO ESCALATION | 234,292.65 | BEVINS M | 1 | 1 |  | MIKE B |  |  |  |  |  |  |  |  | 10-065 |  |  |  |  |  | APP |  |  | 10-001B |  | 10-003 |  |  |  |  |  |  |  |
| 13411105d |  | Vend Fab Curved Dipoles Peg Point #2 Receipt of Core Materials |  | 63d | 2009-11-18 | 2010-02-26 | 13411105c FS-63d | 46d | 0d | PROCUREMENT>$50K 69 NO ESCALATION | 263,857.99 | BEVINS M | 1 | 1 |  | MIKE B |  |  |  |  |  |  |  |  | 10-065 |  |  |  |  |  | APP |  |  |  |  | 10-003 |  |  |  |  |  |  |  |
| 13411105f |  | Vend Fab Curved Dipoles Peg Point #3 JLab Approval of First Article XU Coil |  | 108d | 2009-11-18 | 2010-04-30 | 13411105d FS-63d | 46d | 0d | PROCUREMENT>$50K 69 NO ESCALATION | 20,800 | BEVINS M | 1 | 1 |  | MIKE B |  |  |  |  |  |  |  |  | 10-065 |  |  |  |  |  | APP |  |  |  |  | 10-003 |  |  |  |  |  |  |  |
| 13411105g |  | Vend Fab Curved Dipoles Peg Point #4 JLab Approval of First Article XU Core Assembly |  | 150d | 2009-11-18 | 2010-06-30 | 13411105f FS-108d | 46d | 0d | PROCUREMENT>$50K 69 NO ESCALATION | 13,978.67 | BEVINS M | 1 | 1 |  | MIKE B |  |  |  |  |  |  |  |  | 10-065 |  |  |  |  |  | APP |  |  |  |  | 10-003 |  |  |  |  |  |  |  |
| 13411105h |  | Vend Fab Curved Dipoles Peg Point #5 Receipt and Acceptance of XU Coils by JLab |  | 150d | 2009-11-18 | 2010-06-30 | 13411105g FS-150d | 46d | 0d | PROCUREMENT>$50K 69 NO ESCALATION | 62,400 | BEVINS M | 1 | 1 |  | MIKE B |  |  |  |  |  |  |  |  | 10-065 |  |  |  |  |  | APP |  |  |  |  | 10-003 |  |  |  |  |  |  |  |
| 13411105j |  | Vend Fab Curved Dipoles Peg Point #6 Receipt and Acceptance of XU Magnet Assemblies by JLab |  | 235d | 2009-11-18 | 2010-10-29 | 13411105h FS-150d | 46d | 0d | PROCUREMENT>$50K 69 NO ESCALATION | 27,957.33 | BEVINS M | 1 | 1 |  | MIKE B |  |  |  |  |  |  |  |  | 10-065 |  |  |  |  |  | APP |  |  |  |  | 10-003 |  |  |  |  |  |  |  |
| 13411105k |  | Vend Fab Curved Dipoles Peg Point #7 Receipt and Acceptance of XM Coils by JLab |  | 272d | 2009-11-18 | 2010-12-30 | 13411105j FS-235d | 46d | 0d | PROCUREMENT>$50K 69 NO ESCALATION | 47,000 | BEVINS M | 1 | 1 |  | MIKE B |  |  |  |  |  |  |  |  | 10-065 |  |  |  |  |  | APP |  |  |  |  | 10-003 |  |  |  |  |  |  |  |
| 13411105n |  | Vend Fab Curved Dipoles Peg Point #8 Receipt and Acceptance of XV Coils by JLab |  | 292d | 2009-11-18 | 2011-01-31 | 13411105k FS-272d | 46d | 0d | PROCUREMENT>$50K 69 NO ESCALATION | 64,426.65 | BEVINS M | 1 | 1 |  | MIKE B |  |  |  |  |  |  |  |  | 10-065 |  |  |  |  |  | APP |  |  |  |  | 10-003 |  |  |  |  |  |  |  |
| 13411105o |  | Vend Fab Curved Dipoles Peg Point #9 Receipt and Acceptance of XV Magnet Assemblies by JLab |  | 292d | 2009-11-18 | 2011-01-31 | 13411105n FS-292d | 46d | 0d | PROCUREMENT>$50K 69 NO ESCALATION | 44,115.99 | BEVINS M | 1 | 1 |  | MIKE B |  |  |  |  |  |  |  |  | 10-065 |  |  |  |  |  | APP |  |  |  |  | 10-003 |  |  |  |  |  |  |  |
| 13411105p |  | Vend Fab Curved Dipoles Peg Point #10 Receipt and Acceptance of BP Coils by JLab |  | 292d | 2009-11-18 | 2011-01-31 | 13411105o FS-292d | 46d | 0d | PROCUREMENT>$50K 69 NO ESCALATION | 69,626.69 | BEVINS M | 1 | 1 |  | MIKE B |  |  |  |  |  |  |  |  | 10-065 |  |  |  |  |  | APP |  |  |  |  | 10-003 |  |  |  |  |  |  |  |
| 13411105q |  | Vend Fab Curved Dipoles Peg Point #11 Receipt and Acceptance of JF Coils by JLab |  | 311d | 2009-11-18 | 2011-02-28 | 13411105p FS-292d | 46d | 0d | PROCUREMENT>$50K 69 NO ESCALATION | 9,600 | BEVINS M | 1 | 1 |  | MIKE B |  |  |  |  |  |  |  |  | 10-065 |  |  |  |  |  | APP |  |  |  |  | 10-003 |  |  |  |  |  |  |  |
| 13411105r |  | Vend Fab Curved Dipoles Peg Point #12 Receipt and Acceptance of XM Magnet Assemblies by JLab |  | 311d | 2009-11-18 | 2011-02-28 | 13411105q FS-311d | 46d | 0d | PROCUREMENT>$50K 69 NO ESCALATION | 28,344 | BEVINS M | 1 | 1 |  | MIKE B |  |  |  |  |  |  |  |  | 10-065 |  |  |  |  |  | APP |  |  |  |  | 10-003 |  |  |  |  |  |  |  |
| 13411105s |  | Vend Fab Curved Dipoles Peg Point #13 Receipt and Acceptance of XX Coils by JLab |  | 334d | 2009-11-18 | 2011-03-31 | 13411105r FS-311d | 46d | 0d | PROCUREMENT>$50K 69 NO ESCALATION | 62,666.68 | BEVINS M | 1 | 1 |  | MIKE B |  |  |  |  |  |  |  |  | 10-065 |  |  |  |  |  | APP |  |  |  |  | 10-003 |  |  |  |  |  |  |  |
| 13411105t |  | Vend Fab Curved Dipoles Peg Point #14 Receipt and Acceptance of JG Magnet Assemblies by JLab |  | 376d | 2009-11-18 | 2011-05-31 | 13411105s FS-334d | 46d | 0d | PROCUREMENT>$50K 69 NO ESCALATION | 42,368 | BEVINS M | 1 | 1 |  | MIKE B |  |  |  |  |  |  |  |  | 10-065 |  |  |  |  |  | APP |  |  |  |  | 10-003 |  |  |  |  |  |  |  |
| 13411105u |  | Vend Fab Curved Dipoles Peg Point #15 Receipt and Acceptance of JH Magnet Assemblies by JLab |  | 441d | 2009-11-18 | 2011-08-31 | 13411105t FS-376d | 46d | 0d | PROCUREMENT>$50K 69 NO ESCALATION | 31,776 | BEVINS M | 1 | 1 |  | MIKE B |  |  |  |  |  |  |  |  | 10-065 |  |  |  |  |  | APP |  |  |  |  | 10-003 |  |  |  |  |  |  |  |
| 13411105v |  | Vend Fab Curved Dipoles Peg Point #16 Receipt and Acceptance of XX Magnet Assemblies by JLab |  | 462d | 2009-11-18 | 2011-09-30 | 13411105u FS-441d | 99d | 0d | PROCUREMENT>$50K 69 NO ESCALATION | 31,635.99 | BEVINS M | 1 | 1 |  | MIKE B |  |  |  |  |  |  |  |  | 10-065 |  |  |  |  |  | APP |  |  |  |  | 10-003 |  |  |  |  |  |  |  |
| 13411135 |  | Proc & Vend Fab Misc shims & Brackets (S/R Dipoles) Labor FY10 |  | 188d | 2010-01-05 | 2010-09-30 | 13411909LOE, 9-100M FS+60d | 399d | 0d | MECH DES [15.22 h]; MECH ENG [15.22 h]; MECH TECH [15.22 h] | 2,326.07 | BEVINS M | 1 | 1 |  | MIKE B | 09-012 |  |  |  |  |  | 08-029 |  | 10-065 |  |  |  |  |  | APP | 08-016 |  |  |  |  | 09-034 | 11-001 | 12-035F |  |  |  |  |
| 13411106 |  | P-2 Vend Fab Curved Dipoles (S/R Dipoles) Original Labor FY10 |  | 171d | 2010-01-29 | 2010-09-30 | 9-100M FS+60d, 13411105b FS-105d, 13411105c FS-105d | 111d | 0d | MECH ENG [68.95 h]; MECH DES [27.58 h] | 5,788.08 | BEVINS M | 1 | 1 |  | MIKE B | 09-012 |  |  |  |  |  | 08-029 |  |  |  |  |  |  |  | APP | 08-016 |  |  |  | 10-003 |  | 11-001 |  |  |  |  |  |
| 13411126 |  | P-2 Vend Fab C Dipoles & Coils (S/R Dipoles) Original Labor FY10 |  | 171d | 2010-01-29 | 2010-09-30 | 13411125b FS-105d | 196d | 0d | MECH ENG [137.9 h]; MECH DES [55.16 h] | 11,576.16 | BEVINS M | 1 | 1 |  | MIKE B | 09-012 |  |  |  |  |  | 08-029 |  |  |  |  |  |  |  | APP | 08-016 | 3411B |  | 07-024 | 10-003 |  | 11-001 |  |  |  |  |  |
| 13411060M |  | Award Contract for H Steel (S/R DIPOLES) | milestone | 0d | 2010-03-22 | 2010-03-22 | 121416010, 13411055, 121411110M | 169d | 0d |  |  | BEVINS M | 1 | 1 |  | MIKE B |  |  |  |  |  |  |  |  |  |  |  |  | 6 |  |  |  |  |  |  |  |  |  |  |  |  |  |  |
| 13411065 |  | P-1 Vend Fab H Steel (S/R Dipoles) Labor FY10 |  | 136d | 2010-03-22 | 2010-09-30 | 13411060M | 169d | 0d | MECH ENG [10.97 h]; MECH DES [21.94 h] | 1,714.94 | BEVINS M | 1 | 1 |  | MIKE B | 09-012 |  |  |  |  |  | 08-029 |  |  |  |  |  |  |  | APP | 08-016 |  |  |  |  |  | 11-001 |  |  |  |  |  |
| 13411065b |  | P-1 Vend Fab H Steel (S/R Dipoles) Procurement |  | 248d | 2010-03-22 | 2011-03-21 | 13411060M | 169d | 0d | PROCUREMENT>$50K 69 NO ESCALATION FY11 | 56,435.33 | BEVINS M | 1 | 1 |  | MIKE B | 09-012 |  |  |  |  |  | 08-029 |  |  |  |  |  |  |  | APP | 08-016 |  |  |  |  |  | 11-001 |  |  |  |  |  |
| 13411108M |  | Deliver First Curved Dipoles (S/R Dipoles) | milestone | 0d | 2010-06-30 | 2010-06-30 | 13411105g, 13411100M FS+208d | 252d | 161d |  |  | BEVINS M | 1 | 1 |  | MIKE B |  |  |  |  |  |  | 08-029 |  |  |  |  |  |  |  | APP | 08-016 |  |  |  | 10-003 |  |  |  |  |  |  |  |
| 13411105w |  | Vend Fab Curved Dipoles Peg Point #17 Additional Material for XH and XY Magnets |  | 21d | 2010-07-01 | 2010-07-30 | 9-100M FS+184d | 99d | 0d | PROCUREMENT<$50K 60 NO ESCALATION | 43,316 | BEVINS M | 1 | 1 |  | MIKE B |  |  |  |  |  |  |  |  | 10-065 |  |  |  |  |  | APP |  |  |  |  |  |  |  |  |  |  |  |  |
| 13411160 |  | Proc Prep Extra Coils FY10 |  | 64d | 2010-07-01 | 2010-09-30 | 9-100M FS+184d | 520d | 0d | MECH DES [59.5 h]; MECH ENG [29.7 h] | 4,647.53 | BEVINS M | 1 | 1 |  | MIKE B |  |  |  |  |  |  |  |  | 10-065 |  |  |  |  |  | APP |  |  |  |  |  |  |  | 12-035F | 10-030 |  |  |  |
| 13411200 |  | Spreader Recombiner Dipole Refurb and Mod Documentation FY10 |  | 64d | 2010-07-01 | 2010-09-30 | 9-100M FS+184d | 340d | 0d | MECH DES [1363.93 h]; MECH ENG [629.51 h] | 103,157.42 | BEVINS M | 1 | 1 |  | MIKE B |  |  |  |  |  |  |  |  | 10-065 |  |  |  |  |  | APP |  |  |  |  |  |  | 11-001 |  |  |  |  |  |
| 13411136 |  | Proc Prep BCOMM and Additional Steel FY10 |  | 63d | 2010-07-02 | 2010-09-30 | 9-100M FS+185d | 285d | 0d | MECH ENG [385.4 h]; MECH DES [444.7 h] | 45,496.82 | BEVINS M | 1 | 1 |  | MIKE B |  |  |  |  |  |  |  |  | 10-065 |  |  |  |  |  | APP |  |  |  |  |  |  |  | 12-035F | 10-030 |  |  |  |
| 13411087F |  | Vend Fab Septa (S/R Dipoles) Material Annealing |  | 65d | 2010-07-30 | 2010-10-29 | 9-100M FS+204d | 506d | 494d | PROCUREMENT<$50K 60 NO ESCALATION; PROCUREMENT>$50K 69 NO ESCALATION | 75,000 | BEVINS M | 1 | 1 |  | MIKE B |  |  |  |  |  |  |  |  | 10-065 | 11-041 | 13-003F |  |  |  | APP |  | 3411A |  |  |  |  |  |  |  |  |  |  |
| 13411105x |  | Vend Fab Curved Dipoles Peg Point #18 Receipt and Acceptance XH and XY Magnets |  | 251d | 2010-09-28 | 2011-09-30 | 13411105w FS+40d | 99d | 0d | PROCUREMENT<$50K 60 NO ESCALATION; PROCUREMENT>$50K 69 NO ESCALATION | 92,000 | BEVINS M | 1 | 1 |  | MIKE B |  |  |  |  |  |  |  |  | 10-065 |  |  |  |  |  | APP |  |  |  |  |  |  |  |  |  |  |  |  |
| 13411065a |  | P-1 Vend Fab H Steel (S/R Dipoles) Labor FY11 |  | 112d | 2010-10-01 | 2011-03-21 | 13411065 | 169d | 0d | MECH ENG [9.03 h]; MECH DES [18.06 h] | 1,456.63 | BEVINS M | 1 | 1 |  | MIKE B | 09-012 |  |  |  |  |  | 08-029 |  |  |  |  |  |  |  | APP | 08-016 |  |  |  |  |  | 11-001 |  |  |  |  |  |
| 13411086BLOE |  | Vend Fab Septa (S/R Dipoles) LABOR FY11 |  | 165d | 2010-10-01 | 2011-06-03 | 13411086ALOE | 362d | 350d | MECH DES [93.6 h]; MECH ENG [267.6 h] | 22,552.67 | BEVINS M | 1 | 1 |  | MIKE B | 09-012 |  |  |  |  |  | 08-029 | 08-059 | 10-065 | 11-041 | 13-003F |  |  | 09-047 | APP | 08-016 | 3411A |  |  |  |  |  |  |  |  |  |  |
| 13411106a |  | P-2 Vend Fab Curved Dipoles (S/R Dipoles) Original Labor FY11 |  | 77d | 2010-10-01 | 2011-01-28 | 13411106 | 111d | 20d | MECH ENG [31.05 h]; MECH DES [12.42 h] | 2,689.62 | BEVINS M | 1 | 1 |  | MIKE B | 09-012 |  |  |  |  |  | 08-029 |  |  |  |  |  |  |  | APP | 08-016 |  |  |  | 10-003 |  | 11-001 |  |  |  |  |  |
| 13411126a |  | P-2 Vend Fab C Dipoles & Coils (S/R Dipoles) Original Labor FY11 |  | 77d | 2010-10-01 | 2011-01-28 | 13411126 | 196d | 150d | MECH ENG [62.1 h]; MECH DES [24.84 h] | 5,379.23 | BEVINS M | 1 | 1 |  | MIKE B | 09-012 |  |  |  |  |  | 08-029 |  |  |  |  |  |  |  | APP | 08-016 | 3411B |  | 07-024 | 10-003 |  | 11-001 |  |  |  |  |  |
| 13411135a |  | Proc & Vend Fab Misc shims & Brackets (S/R Dipoles) Labor FY11 |  | 248d | 2010-10-01 | 2011-09-30 | 13411135 | 399d | 0d | MECH TECH [20.08 h]; MECH DES [20.08 h]; MECH ENG [20.08 h] | 3,166.62 | BEVINS M | 1 | 1 |  | MIKE B | 09-012 |  |  |  |  |  | 08-029 |  | 10-065 |  |  |  |  |  | APP | 08-016 |  |  |  |  | 09-034 | 11-001 | 12-035F |  | 12-001 |  |  |
| 13411136a |  | Proc Prep BCOMM and Additional Steel FY11 |  | 22d | 2010-10-01 | 2010-11-01 | 13411136 | 285d | 0d | MECH DES [155.3 h]; MECH ENG [134.6 h] | 16,395.47 | BEVINS M | 1 | 1 |  | MIKE B |  |  |  |  |  |  |  |  | 10-065 |  |  |  |  |  | APP |  |  |  |  |  |  |  | 12-035F | 10-030 |  |  |  |
| 13411165 |  | Proc Prep Extra Coils FY11 |  | 22d | 2010-10-01 | 2010-11-01 | 13411160 | 520d | 0d | MECH ENG [10.3 h]; MECH DES [20.5 h] | 1,656.83 | BEVINS M | 1 | 1 |  | MIKE B |  |  |  |  |  |  |  |  | 10-065 |  |  |  |  |  | APP |  |  |  |  |  |  |  | 12-035F | 10-030 |  |  |  |
| 13411200a |  | Spreader Recombiner Dipole Refurb and Mod Documentation FY11 |  | 58d | 2010-10-01 | 2010-12-30 | 13411200 | 340d |  | MECH ENG [570.49 h]; MECH DES [1236.07 h] | 96,464.55 | BEVINS M | 1 | 1 |  | MIKE B |  |  |  |  |  |  |  |  | 10-065 |  |  |  |  |  | APP |  |  |  |  |  |  | 11-001 |  |  |  |  |  |
| 13411911LOE |  | FY11 Mngmnt & Oversight (S/R Dipoles) |  | 248d | 2010-10-01 | 2011-09-30 | 13411910LOE | 20d | 0d | SR STAFF [280 h] | 30,662.8 | BEVINS M | 1 | 1 |  | MIKE B |  |  |  |  |  |  |  |  |  |  |  |  |  |  |  |  |  |  |  |  |  |  |  |  |  |  |  |
| 13411136M |  | Award Vend Fab BCOMM and Additional Steel | milestone | 0d | 2010-11-02 | 2010-11-02 | 13411136a | 285d | 0d |  |  | BEVINS M | 1 | 1 |  | MIKE B |  |  |  |  |  |  |  |  | 10-065 |  |  |  | 6 |  |  |  |  |  |  |  |  |  | 12-035F | 10-030 |  | IPL |  |
| 13411137 |  | Vend Fab BCOMM and Additional Steel Oversight |  | 163d | 2010-11-02 | 2011-07-01 | 13411136M | 520d | 236d | MECH ENG [200 h] | 13,590 | BEVINS M | 1 | 1 |  | MIKE B |  |  |  |  |  |  |  |  | 10-065 |  |  |  |  |  | APP |  |  |  |  |  |  |  | 12-035F | 10-030 |  |  |  |
| 13411138 |  | Vend Fab BCOMM and Additional Steel (Materials) |  | 226d | 2010-11-02 | 2011-09-30 | 13411136M | 285d | 0d | PROCUREMENT<$50K 60; PROCUREMENT>$50K 69 | 95,000 | BEVINS M | 1 | 1 |  | MIKE B |  |  |  |  |  |  |  |  | 10-065 |  |  |  |  |  | APP |  |  |  |  |  |  |  | 12-035F | 10-030 |  |  | 11-057 |

Notes:
- 13411125: Corrective Actions: THIS WAS INCREASED TO FIX AN ERROR / WHICH WE SAW DURING THE CR07-024 WHICH WAS A DOUBLE ENTRY
- 13411125b: Corrective Actions: THIS WAS INCREASED TO FIX AN ERROR / WHICH WE SAW DURING THE CR07-024 WHICH WAS A DOUBLE ENTRY
- 13411126: Corrective Actions: THIS WAS INCREASED TO FIX AN ERROR / WHICH WE SAW DURING THE CR07-024 WHICH WAS A DOUBLE ENTRY
- 13411126a: Corrective Actions: THIS WAS INCREASED TO FIX AN ERROR / WHICH WE SAW DURING THE CR07-024 WHICH WAS A DOUBLE ENTRY
- 13411136M: Explanation: IPL from 6 GeV BIA 534213060 and / 534213120

| ID | Activity | Type | Duration | Start | Finish | Predecessors | Total float | Free float | Calendar | Resources | Cost | RESP - Responsibility | STRT%COMP for CM EVM | FNSH%COMP for CM EVM | Milestone Level | Inter Project Link (IPL) | CAM RESPONSIBLE | CR 10-030 | CR 10-065 | CR 12-035 | Advance Purchase Plan > 500K | CR 08-016 | CR 08-029 | CR 10-003 | 12 GEV MAJOR PROCUREMENT CATAGORY | CR 11-041 | CR 13-003 | CR 09-047 | CR 10-001 | CR 12-001 | CR 09-012 | CR 09-034 | CR 11-001 | CR 11-057 | CR 08-059 | CR 12-008 | CR 13-014 | ReBaseline Actuals Adjustment | BOE NOTES | Original Activity ID Rebaseline | Over Under Fixed | EVMS Reporting Codes | BOE Procurement | CR 13-015 | Post Rebaseline | Obligated Prior to Rebaseline | BOE Labor | Temple/Lehman | CR 14-001 |
| --- | --- | --- | --- | --- | --- | --- | --- | --- | --- | --- | --- | --- | --- | --- | --- | --- | --- | --- | --- | --- | --- | --- | --- | --- | --- | --- | --- | --- | --- | --- | --- | --- | --- | --- | --- | --- | --- | --- | --- | --- | --- | --- | --- | --- | --- | --- | --- | --- | --- |
| 13411170M | Award Vend Fab Extra Coils | milestone | 0d | 2010-11-02 | 2010-11-02 | 13411165 | 520d | 0d |  |  |  | BEVINS M | 1 | 1 | 6 | IPL | MIKE B | 10-030 | 10-065 | 12-035F |  |  |  |  |  |  |  |  |  |  |  |  |  |  |  |  |  |  |  |  |  |  |  |  |  |  |  |  |  |
| 13411175 | Vend Fab Extra Coils Oversight |  | 163d | 2010-11-02 | 2011-07-01 | 13411170M | 520d | 236d |  | MECH DES [40 h]; MECH ENG [560 h] | 39,919.2 | BEVINS M | 1 | 1 |  |  | MIKE B | 10-030 | 10-065 | 12-035F | APP |  |  |  |  |  |  |  |  |  |  |  |  |  |  |  |  |  |  |  |  |  |  |  |  |  |  |  |  |
| 13411180 | Vend Fab Extra Coils 1st Article |  | 76d | 2010-11-02 | 2011-03-01 | 13411170M | 520d | 0d |  |  |  | BEVINS M | 1 | 1 |  |  | MIKE B | 10-030 | 10-065 | 12-035F | APP |  |  |  |  |  |  |  |  |  |  |  |  |  |  |  |  |  |  |  |  |  |  |  |  |  |  |  |  |
| 13411185 | Vend Fab Extra Coils Production (19) |  | 163d | 2010-11-02 | 2011-07-01 | 13411180 FS-76d | 520d | 0d |  | PROCUREMENT<$50K 60 | 46,435.5 | BEVINS M | 1 | 1 |  |  | MIKE B | 10-030 | 10-065 | 12-035F | APP |  |  |  |  |  |  |  |  |  |  |  |  |  |  |  |  |  |  |  |  |  |  |  |  |  |  |  |  |
| 13411195 | Magnet End Shim Form Factor Documentation |  | 97d | 2010-11-03 | 2011-03-31 | 9-110M FS+23d | 585d | 301d |  | MECH ENG [280 h]; MECH TECH [760 h] | 51,759.2 | BEVINS M | 1 | 1 |  |  | MIKE B |  | 10-065 | 12-035F | APP |  |  |  |  |  |  |  |  |  |  |  |  |  |  |  |  |  |  |  |  |  |  |  |  |  |  |  |  |
| 13411066 | P-2 Vend Fab H Steel (S/R Dipoles) |  | 170d | 2011-01-04 | 2011-09-02 | 13411065b FS-53d, 13411065a FS-53d | 169d | 0d |  | PROCUREMENT>$50K 69; MECH ENG [20 h] | 67,286.12 | BEVINS M | 1 | 1 |  |  | MIKE B |  |  |  | APP | 08-016 | 08-029 |  |  |  |  |  |  |  |  |  |  |  |  |  |  |  |  |  |  |  |  |  |  |  |  |  |  |
| 13411190 | Receive and Inspect Extra Coils |  | 107d | 2011-02-01 | 2011-07-01 | 13411185 FS-107d, 13411180 FS-20d | 520d | 236d |  | MECH ENG [120 h]; MECH TECH [200 h]; COMP SCIENT [40 h] | 19,311.6 | BEVINS M | 1 | 1 |  |  | MIKE B | 10-030 | 10-065 | 12-035F | APP |  |  |  |  |  |  |  |  |  |  |  |  |  |  |  |  |  |  |  |  |  |  |  |  |  |  |  |  |
| 13411110M | Delivery Complete for Curved Dipoles (S/R DIPOLES) | milestone | 0d | 2011-02-28 | 2011-02-28 | 13411106a, 13411105r, 13411108M | 91d | 45d |  |  |  | BEVINS M | 1 | 1 | 6 |  | MIKE B |  | 10-065 |  |  |  | 08-029 | 10-003 |  |  |  |  |  |  |  |  |  |  |  |  |  |  |  |  |  |  |  |  |  |  |  |  |  |
| 13411087G | Vend Fab Septa (S/R Dipoles) Peg Point #1 Receipt of Material |  | 110d | 2011-03-29 | 2011-08-31 | 9-110M FS+117d | 181d | 0d |  | PROCUREMENT>$50K 69 NO ESCALATION; PROCUREMENT<$50K 60 NO ESCALATION | 74,750 | BEVINS M | 1 | 1 |  |  | MIKE B |  | 10-065 |  | APP |  |  |  | 3411A | 11-041 | 13-003F |  |  |  |  |  |  |  |  |  |  |  |  |  |  |  |  |  |  |  |  |  |  |
| 13411087H | Vend Fab Septa (S/R Dipoles) Peg Point #2 Acceptance and Shipping of First Article ZA Magnet Assembly |  | 172d | 2011-03-29 | 2011-11-30 | 13411087G FS-110d | 181d | 0d |  | PROCUREMENT>$50K 69 NO ESCALATION | 55,250 | BEVINS M | 1 | 1 |  |  | MIKE B |  | 10-065 |  | APP |  |  |  | 3411A | 11-041 | 13-003F |  |  |  |  |  |  |  |  |  |  |  |  |  |  |  |  |  |  |  |  |  |  |
| 13411087J | Vend Fab Septa (S/R Dipoles) Peg Point #3 Delivery and Acceptance of Quantity 4 ZA Magnet Assemblies |  | 188d | 2011-03-29 | 2011-12-29 | 13411087H FS-172d | 181d | 0d |  | PROCUREMENT>$50K 69 NO ESCALATION | 170,000 | BEVINS M | 1 | 1 |  |  | MIKE B |  | 10-065 |  | APP |  |  |  | 3411A | 11-041 | 13-003F |  |  |  |  |  |  |  |  |  |  |  |  |  |  |  |  |  |  |  |  |  |  |
| 13411087K | Vend Fab Septa (S/R Dipoles) Peg Point #4 Delivery and Acceptance of Quantity 3 ZA Magnet Assemblies |  | 209d | 2011-03-29 | 2012-01-31 | 13411087J FS-188d | 181d | 0d |  | PROCUREMENT>$50K 69 NO ESCALATION | 127,500 | BEVINS M | 1 | 1 |  |  | MIKE B |  | 10-065 |  | APP |  |  |  | 3411A | 11-041 | 13-003F |  |  |  |  |  |  |  |  |  |  |  |  |  |  |  |  |  |  |  |  |  |  |
| 13411087N | Vend Fab Septa (S/R Dipoles) Peg Point #5 Delivery and Acceptance of ZA Spare Coil Set |  | 209d | 2011-03-29 | 2012-01-31 | 13411087K FS-209d | 181d | 0d |  | PROCUREMENT>$50K 69 NO ESCALATION | 21,500 | BEVINS M | 1 | 1 |  |  | MIKE B |  | 10-065 |  | APP |  |  |  | 3411A | 11-041 | 13-003F |  |  |  |  |  |  |  |  |  |  |  |  |  |  |  |  |  |  |  |  |  |  |
| 13411087P | Vend Fab Septa (S/R Dipoles) Peg Point #6 Delivery and Acceptance of Quantity 2 YA Magnet Assemblies |  | 229d | 2011-03-29 | 2012-02-29 | 13411087N FS-209d | 181d | 0d |  | PROCUREMENT>$50K 69 NO ESCALATION | 79,000 | BEVINS M | 1 | 1 |  |  | MIKE B |  | 10-065 |  | APP |  |  |  | 3411A | 11-041 | 13-003F |  |  |  |  |  |  |  |  |  |  |  |  |  |  |  |  |  |  |  |  |  |  |
| 13411087Q | Vend Fab Septa (S/R Dipoles) Peg Point #7 Delivery and Acceptance of Quantity 2 ZB Coil Sets |  | 229d | 2011-03-29 | 2012-02-29 | 13411087P FS-229d | 181d | 169d |  | PROCUREMENT>$50K 69 NO ESCALATION | 69,000 | BEVINS M | 1 | 1 |  |  | MIKE B |  | 10-065 |  | APP |  |  |  | 3411A | 11-041 | 13-003F |  |  |  |  |  |  |  |  |  |  |  |  |  |  |  |  |  |  |  |  |  |  |
| 13411087C5 | Vend Fab Septa (S/R Dipoles) Deliver (3) ZA Magnet Assemblies (WANG Additional Cost to Terminate) |  | 42d | 2011-06-01 | 2011-07-29 | 9-110M FS+162d | 323d | 311d |  | PROCUREMENT>$50K 69 NO ESCALATION | -127,534 | BEVINS M | 1 | 1 |  |  | MIKE B |  | 10-065 |  | APP |  |  |  | 3411A | 11-041 | 13-003F | 09-047 | 10-001A |  |  |  |  |  |  |  |  |  |  |  |  |  |  |  |  |  |  |  |  |
| 13411087D05 | Vend Fab Septa (S/R Dipoles) Deliver ZA Spare Coil Set (Reverse Entry per CR 11-041) |  | 42d | 2011-06-01 | 2011-07-29 | 9-110M FS+162d | 323d | 311d |  | PROCUREMENT>$50K 69 NO ESCALATION | -23,800 | BEVINS M | 1 | 1 |  |  | MIKE B |  | 10-065 |  | APP |  |  |  | 3411A | 11-041 | 13-003F | 09-047 | 10-001A |  |  |  |  |  |  |  |  |  |  |  |  |  |  |  |  |  |  |  |  |
| 13411087D15 | Vend Fab Septa (S/R Dipoles) Deliver (2) YA Magnet Assemblies (Reverse Entry per CR 11-041) |  | 127d | 2011-06-01 | 2011-11-30 | 9-110M FS+162d | 238d | 226d |  | PROCUREMENT>$50K 69 NO ESCALATION | -68,850 | BEVINS M | 1 | 1 |  |  | MIKE B |  | 10-065 |  | APP |  |  |  | 3411A | 11-041 | 13-003F | 09-047 | 10-001A |  |  |  |  |  |  |  |  |  |  |  |  |  |  |  |  |  |  |  |  |
| 13411087D7 | Vend Fab Septa (S/R Dipoles) Deliver (2) ZB Coil Sets (Reverse Entry per CR 11-041) |  | 144d | 2011-06-01 | 2011-12-30 | 9-110M FS+162d | 221d | 209d |  | PROCUREMENT>$50K 69 NO ESCALATION | -51,000 | BEVINS M | 1 | 1 |  |  | MIKE B |  | 10-065 |  | APP |  |  |  | 3411A | 11-041 | 13-003F | 09-047 | 10-001A |  |  |  |  |  |  |  |  |  |  |  |  |  |  |  |  |  |  |  |  |
| 13411087F5 | Stangenes Septa Contract Oversight Labor FY11 |  | 86d | 2011-06-01 | 2011-09-30 | 9-110M FS+162d | 181d | 0d |  | MECH ENG [453.93 h] | 30,844.54 | BEVINS M | 1 | 1 |  |  | MIKE B |  | 10-065 |  | APP |  |  |  | 3411A | 11-041 | 13-003F |  |  | 12-001 |  |  |  |  |  |  |  |  |  |  |  |  |  |  |  |  |  |  |  |
| 13411087F7 | Completion of Core Macining |  | 144d | 2011-06-01 | 2011-12-30 | 9-110M FS+162d | 221d | 209d |  | PROCUREMENT<$50K 60 NO ESCALATION; PROCUREMENT>$50K 69 NO ESCALATION | 100,255 | BEVINS M | 1 | 1 |  |  | MIKE B |  | 10-065 |  | APP |  |  |  | 3411A | 11-041 | 13-003F |  |  |  |  |  |  |  |  |  |  |  |  |  |  |  |  |  |  |  |  |  |  |
| 13411140 | Mag Measurment of New C & Curved Dipoles (S/R Dipoles) FY11 |  | 26d | 2011-08-25 | 2011-09-30 | 13411110M FS+80d, 13411130M FS-5d | 46d | 0d |  | MECH TECH [84.8 h]; MECH ENG [56 h] | 7,457.54 | BEVINS M | 1 | 1 |  |  | MIKE B |  | 10-065 |  |  |  | 08-029 | 10-003 |  |  |  |  |  | 12-001 |  |  |  |  |  |  |  |  |  |  |  |  |  |  |  |  |  |  |  |
| 13411130M | Delivery Complete for C Dipoles & Coils (S/R DIPOLES) (IPL 534213060 and 534213120) | milestone | 0d | 2011-08-31 | 2011-08-31 | 13411126a, 13411105u | 46d | 0d |  |  |  | BEVINS M | 1 | 1 | 6 | IPL | MIKE B |  | 10-065 |  |  |  | 08-029 | 10-003 |  |  |  |  |  |  |  |  |  |  |  |  |  |  |  |  |  |  |  |  |  |  |  |  |  |
| 13411070M | Delivery Complete for H Steel for S/R Dipoles (S/R DIPOLES) | milestone | 0d | 2011-09-02 | 2011-09-02 | 13411066 | 169d |  |  |  |  | BEVINS M | 1 | 1 | 6 |  | MIKE B |  |  |  |  |  | 08-029 |  |  |  |  |  |  |  |  |  |  |  |  |  |  |  |  |  |  |  |  |  |  |  |  |  |  |
| 13411087F5a | Stangenes Septa Contract Oversight Labor FY12 |  | 98d | 2011-10-03 | 2012-02-29 | 13411087F5 | 181d | 169d |  | MECH ENG [517.27 h] | 36,270.97 | BEVINS M | 1 | 1 |  |  | MIKE B |  | 10-065 |  | APP |  |  |  | 3411A | 11-041 | 13-003F |  |  | 12-001 |  |  |  |  |  |  |  |  |  |  |  |  |  |  |  |  |  |  |  |
| 13411135ab | Proc & Vend Fab Misc shims & Brackets (S/R Dipoles) Labor FY12 |  | 58d | 2011-10-03 | 2011-12-30 | 13411135a | 399d | 115d |  | MECH TECH [4.7 h]; MECH DES [4.7 h]; MECH ENG [4.7 h] | 764.83 | BEVINS M | 1 | 1 |  |  | MIKE B |  | 10-065 | 12-035F | APP | 08-016 | 08-029 |  |  |  |  |  |  | 12-001 | 09-012 | 09-034 | 11-001 |  |  |  |  |  |  |  |  |  |  |  |  |  |  |  |  |
| 13411138a | Vend Fab BCOMM and Additional Steel (Machining) |  | 120d | 2011-10-03 | 2012-03-30 | 9-120M, 13411138 | 285d | 0d |  | PROCUREMENT<$50K 60; PROCUREMENT>$50K 69 | 168,173.9 | BEVINS M | 1 | 1 |  |  | MIKE B |  | 10-065 | 12-035F | APP |  |  |  |  |  |  |  |  |  |  |  |  | 11-057 |  |  |  |  |  |  |  |  |  |  |  |  |  |  |  |
| 13411140a | Mag Measurment of New C & Curved Dipoles (S/R Dipoles) FY12 |  | 104d | 2011-10-03 | 2012-03-08 | 13411140 | 46d |  |  | MECH TECH [339.2 h]; MECH ENG [224 h] | 30,780.93 | BEVINS M | 1 | 1 |  |  | MIKE B |  | 10-065 |  |  |  | 08-029 | 10-003 |  |  |  |  |  | 12-001 |  |  |  |  |  |  |  |  |  |  |  |  |  |  |  |  |  |  |  |
| 13411912LOE | FY12 Mngmnt & Oversight (S/R Dipoles) |  | 247d | 2011-10-03 | 2012-09-28 | 13411911LOE | 20d | 0d |  | SR STAFF [280 h] | 31,640 | BEVINS M | 1 | 1 |  |  | MIKE B |  |  |  |  |  |  |  |  |  |  |  |  |  |  |  |  |  |  |  |  |  |  |  |  |  |  |  |  |  |  |  |  |
| 13411145 | Mag Measurement of Septa's (S/R Dipoles) |  | 98d | 2011-11-30 | 2012-04-25 | 13416048M FS-125d, 13411090M FS-227d, 13411087A | 12d |  |  | MECH ENG [280 h]; MECH TECH [496 h] | 41,675.84 | BEVINS M | 1 | 1 |  |  | MIKE B |  | 10-065 |  |  |  | 08-029 |  |  | 11-041 |  | 09-047 |  |  |  |  |  |  | 08-059 |  |  |  |  |  |  |  |  |  |  |  |  |  |  |
| 13411088M | First Septa Dipole Delivery | milestone | 0d | 2011-11-30 | 2011-11-30 | 13411087A, 13411087H | 238d | 226d |  |  |  | BEVINS M | 1 | 1 |  |  | MIKE B |  | 10-065 |  | APP | 08-016 | 08-029 |  |  | 11-041 | 13-003F | 09-047 |  |  |  |  |  |  |  |  |  |  |  |  |  |  |  |  |  |  |  |  |  |
| 13411196 | Procurement of CNC Machining Center |  | 79d | 2011-12-01 | 2012-03-30 | 9-120M FS+41d | 30d |  |  | PROCUREMENT<$50K 60 NO ESCALATION; PROCUREMENT>$50K 69 NO ESCALATION | 155,000 | BEVINS M | 1 | 1 |  |  | MIKE B |  |  |  |  |  |  |  |  |  |  |  |  |  |  |  |  |  |  | 12-008 |  |  |  |  |  |  |  |  |  |  |  |  |  |
| 13411135b | Proc & Vend Fab Misc shims & Brackets (S/R Dipoles) Procurement |  | 91d | 2011-12-14 | 2012-04-30 | 13411909LOE, 9-120M FS+50d | 316d | 32d |  | PROCUREMENT<$50K 60 | 20,876.92 | BEVINS M | 1 | 1 |  |  | MIKE B |  | 10-065 | 12-035F | APP | 08-016 | 08-029 |  |  |  |  |  |  |  | 09-012 | 09-034 | 11-001 | 11-057 |  |  |  |  |  |  |  |  |  |  |  |  |  |  |  |
| 13411139 | Receive and Inspect BCOMM and Additional Steel |  | 107d | 2012-04-02 | 2012-08-30 | 13411138 FS-107d, 13411138a | 285d | 1d |  | MECH ENG [80 h]; COMP SCIENT [80 h]; MECH TECH [160 h] | 17,969.6 | BEVINS M | 1 | 1 |  |  | MIKE B | 10-030 | 10-065 | 12-035F | APP |  |  |  |  |  |  |  |  |  |  |  |  |  |  |  |  |  |  |  |  |  |  |  |  |  |  |  |  |
| 13411088 | Septa Core Shipping Costs |  | 20d | 2012-10-01 | 2012-10-26 | 9-130M | 12d | 0d |  | PROCUREMENT>$50K 69 NO ESCALATION | 12,000 | BEVINS M | 1 | 1 |  |  | MIKE B |  | 10-065 |  | APP |  |  |  | 3411A | 11-041 | 13-003 |  |  |  |  |  |  |  |  |  |  |  |  |  |  |  |  |  |  |  |  |  |  |
| 13411150LOE | Management Oversight of Septa's (S/R Dipoles) 2012 ETC |  | 80d | 2012-10-01 | 2013-01-31 | 9-130M | 157d |  |  | MECH ENG [690.8 h] | 49,986.29 | BEVINS M | 1 | 1 |  |  | MIKE B |  | 10-065 |  |  |  | 08-029 |  |  | 11-041 | 13-003 | 09-047 |  |  |  |  |  |  | 08-059 |  |  |  |  |  |  |  |  |  |  |  |  |  |  |
| 13411090M | Delivery Complete for Septa (S/R DIPOLES) | milestone | 0d | 2012-10-26 | 2012-10-26 | 13411087D15, 13411087F, 13411087D10, 13411087F5a, 13411087C, 13411087D7, 13411087D5, 13411087F7, 13411088M, 13411087, 13411087D, 13411087Q, 13411087D05, 13411087A, 13411087C5, 13411086BLOE, 13411087B, 13411088 | 12d | 0d |  |  |  | BEVINS M | 1 | 1 | 6 |  | MIKE B |  | 10-065 |  |  |  | 08-029 |  |  | 11-041 | 13-003 | 09-047 |  |  |  |  |  |  | 08-059 |  |  |  |  |  |  |  |  |  |  |  |  |  |  |
| 13411950 | Re-Baseline Actuals Adjustment |  | 1d | 2013-08-30 | 2013-08-30 | 9-130M FS+227d | 20d |  |  | PROCUREMENT>$50K 69 NO ESCALATION | 854,402.24 | BEVINS M | 1 | 1 |  |  | MIKE B |  |  |  |  |  |  |  |  |  |  |  |  |  |  |  |  |  |  |  | 13-014 | ADJ |  |  |  |  |  |  |  |  |  |  |  |
| 23411087N | Vend Fab Septa (S/R Dipoles) Peg Point #5 Delivery and Acceptance of ZA Spare Coil Set |  | 31d | 2013-09-03 | 2013-10-15 | 9-130M FS+228d | 3d | 0d | 8/5 M-F w/JLAB Holidays ReBaseline | PROCUREMENT>$50K 69 NO ESCALATION | 21,500 | BEVINS M | 1 | 1 |  |  | MIKE B |  | 10-065 |  | APP |  |  |  | 3411A | 11-041 | 13-003F |  |  |  |  |  |  |  |  |  |  |  | Open Obligation | 23411087N | y | D | OB | 13-015 | PR | OB |  |  |  |
| 23411087Q | Vend Fab Septa (S/R Dipoles) Peg Point #7 Delivery and Acceptance of Quantity 2 ZB Coil Sets |  | 31d | 2013-09-03 | 2013-10-15 | 23411087N FS-31d | 3d | 0d | 8/5 M-F w/JLAB Holidays ReBaseline | PROCUREMENT>$50K 69 NO ESCALATION | 34,500 | BEVINS M | 1 | 1 |  |  | MIKE B |  | 10-065 |  | APP |  |  |  | 3411A | 11-041 | 13-003F |  |  |  |  |  |  |  |  |  |  |  | Open Obligation | 23411087Q | y | D | OB | 13-015 | PR | OB |  |  |  |
| 23411145 | Mag Measurement of Septa's (S/R Dipoles) FY13 |  | 9d | 2013-09-18 | 2013-09-30 | 23411090M FS-20d | 3d | 0d | 8/5 M-F w/JLAB Holidays ReBaseline | MECH ENG [12.69 h]; MECH TECH [52.11 h] | 3,308.01 | BEVINS M | 1 | 1 |  |  | MIKE B |  | 10-065 |  |  |  | 08-029 |  |  | 11-041 |  | 09-047 |  |  |  |  |  |  | 08-059 |  |  |  |  | 23411145 |  | H |  | 13-015 | PR |  | PE | LR13 |  |
| 23411145a | Mag Measurement of Septa's (S/R Dipoles) FY14 |  | 11d | 2013-10-01 | 2013-10-15 | 23411145, 23411090M FS-20d | 3d |  | 8/5 M-F w/JLAB Holidays ReBaseline | MECH ENG [15.51 h]; MECH TECH [63.69 h] | 4,171.94 | BEVINS M | 1 | 1 |  |  | MIKE B |  | 10-065 |  |  |  | 08-029 |  |  | 11-041 |  | 09-047 |  |  |  |  |  |  | 08-059 |  |  |  |  | 23411145 |  | H |  | 13-015 | PR |  | PE | LR13 | 14-001 |
| 23411090M | Delivery Complete for Septa (S/R DIPOLES) | milestone | 0d | 2013-10-15 | 2013-10-15 | 23411087Q | 3d | 0d | 8/5 M-F w/JLAB Holidays ReBaseline |  |  | BEVINS M | 1 | 1 | 6 |  | MIKE B |  | 10-065 |  |  |  | 08-029 |  |  | 11-041 | 13-003 | 09-047 |  |  |  |  |  |  | 08-059 |  |  |  |  | 23411090M |  | M |  | 13-015 | PR |  |  |  |  |

Notes:
- 13411170M: Explanation: IPL from 6 GeV BIA 534213060 and / 534213120
- 13411130M: Explanation: IPL from 6 GeV BIA 534213060 and / 534213120

| ID | WBS | Activity | Type | Duration | Start | Finish | Predecessors | Total float | Free float | Resources | Cost | RESP - Responsibility | STRT%COMP for CM EVM | FNSH%COMP for CM EVM | CR 08-016 | CAM RESPONSIBLE | CR 09-012 | CR 10-030 | CR 10-065 | CR 11-057 | CR 12-035 | CR 12-039 | Milestone Level | CR 12-053 | CR 13-014 | ReBaseline Actuals Adjustment |
| --- | --- | --- | --- | --- | --- | --- | --- | --- | --- | --- | --- | --- | --- | --- | --- | --- | --- | --- | --- | --- | --- | --- | --- | --- | --- | --- |
|  | 2 | **1.3.4.1.2 QUADRUPOLES** |  |  |  |  |  |  |  |  |  |  |  |  |  |  |  |  |  |  |  |  |  |  |  |  |
|  | 3 | **1.3.4.1.3 CORRECTORS** |  |  |  |  |  |  |  |  |  |  |  |  |  |  |  |  |  |  |  |  |  |  |  |  |
|  | 4 | **1.3.4.1.4 STANDS** |  |  | 2010-01-05 | 2013-08-30 |  |  |  |  |  |  |  |  |  |  |  |  |  |  |  |  |  |  |  |  |
| 13414055 |  | Vend Fab S/R Cartridges & Brackets (S/R Stands) (Original) |  | 37d | 2010-01-05 | 2010-02-26 | 9-100M FS+60d | 549d |  | MECH DES [21.3 h]; MECH TECH [6.82 h]; MECH ENG [9.55 h] | 1,877.15 | BEVINS M | 1 | 1 | 08-016 | MIKE B | 09-012 | 10-030 |  |  |  |  |  |  |  |  |
| 13414015 |  | Prcrmnt Prep of New S/R Stands (S/R Stands) Initial |  | 55d | 2010-03-01 | 2010-05-14 | 9-100M FS+97d, 121414016, 121414015a, 121416010, 121414020a | 298d | 137d | MECH ENG [1600 h]; MECH DES [3200 h] | 250,128 | BEVINS M | 1 | 1 |  | MIKE B |  | 10-030 | 10-065 | 11-057 | 12-035F | 12-039F |  |  |  |  |
| 13414017 |  | Prcrmnt Prep of New S/R Stands (S/R Stands) Final |  | 207d | 2010-12-01 | 2011-09-30 | 121414015a, 9-110M FS+41d, 13414015, 121414020a, 121414016, 121416010 | 161d | 141d | MECH DES [1600 h]; MECH ENG [800 h] | 129,048 | BEVINS M | 1 | 1 |  | MIKE B |  | 10-030 | 10-065 | 11-057 | 12-035F | 12-039F |  |  |  |  |
| 13414100 |  | Vend Fab New Girders for S/R (S/R Stands) |  | 83d | 2011-04-01 | 2011-07-28 | 9-110M FS+120d | 502d | 218d | PROCUREMENT>$50K 69 | 26,829.4 | BEVINS M | 1 | 1 |  | MIKE B |  | 10-030 | 10-065 |  | 12-035F |  |  |  |  |  |
| 13414060 |  | Procurement Prep of S/R Brackets (S/R Stands) |  | 88d | 2011-05-27 | 2011-09-30 | 9-120M FS-88d | 75d | 55d | MECH ENG [240 h]; MECH DES [160 h] | 23,776.8 | BEVINS M | 1 | 1 |  | MIKE B |  | 10-030 | 10-065 | 11-057 | 12-035F |  |  |  |  |  |
| 13414022LOE |  | Vend Fab New S/R Stands (S/R Stands) Oversight |  | 101d | 2011-12-14 | 2012-05-14 | 13414020M FS-91d | 174d | 154d | MECH DES [80 h]; MECH ENG [120 h] | 12,268 | BEVINS M | 1 | 1 |  | MIKE B |  | 10-030 | 10-065 | 11-057 | 12-035F |  |  |  |  |  |
| 13414065M |  | Award Contract for Brackets (S/R Stands) | milestone | 0d | 2011-12-21 | 2011-12-21 | 9-120M FS+55d, 13414060 | 20d | 0d |  |  | BEVINS M | 1 | 1 |  | MIKE B |  | 10-030 | 10-065 | 11-057 | 12-035F |  | 6 |  |  |  |
| 13414070LOE |  | Vend Fab S/R Brackets (S/R Stands) Oversight |  | 65d | 2011-12-21 | 2012-03-30 | 13414065M, 13414060 | 129d | 109d | MECH DES [40 h]; MECH ENG [40 h] | 4,731.6 | BEVINS M | 1 | 1 |  | MIKE B |  | 10-030 | 10-065 | 11-057 | 12-035F |  |  |  |  |  |
| 13414075 |  | Vend Fab S/R Brackets (S/R Stands) |  | 192d | 2011-12-21 | 2012-09-28 | 13414065M | 20d | 0d | PROCUREMENT>$50K 69; PROCUREMENT<$50K 60 | 86,250.23 | BEVINS M | 1 | 1 |  | MIKE B |  | 10-030 | 10-065 | 11-057 | 12-035 |  |  |  |  |  |
| 13414090 |  | Receive and Inspect S/R Brackets (S/R Stands) Frozen Per CR 12-035 |  | 9d | 2012-03-20 | 2012-03-30 | 9-120M FS+111d | 129d | 109d | MECH TECH [72 h]; MECH ENG [18 h]; MECH DES [24 h] | 5,617.92 | BEVINS M | 1 | 1 |  | MIKE B |  | 10-030 | 10-065 | 11-057 | 12-035 |  |  |  |  |  |
| 13414027 |  | Receive and Inspect to S/R Stands Frozen Per CR 12-035 |  | 3d | 2012-03-28 | 2012-03-30 | 9-120M FS+117d | 205d | 185d | MECH TECH [42.35 h]; MECH ENG [7.06 h]; MECH DES [3.53 h] | 2,547.12 | BEVINS M | 1 | 1 |  | MIKE B |  | 10-030 | 10-065 | 11-057 | 12-035 |  |  |  |  |  |
| 13414028 |  | Reverse Entry Per CR 12-035 |  | 15d | 2012-04-02 | 2012-04-20 | 9-120M FS+120d | 112d |  | MECH TECH [-114.35 h]; MECH ENG [-25.06 h]; MECH DES [-27.53 h] | -8,165.04 | BEVINS M | 1 | 1 |  | MIKE B |  | 10-030 | 10-065 | 11-057 | 12-035 |  |  |  |  |  |
| 13414020M |  | Award Contract for New S/R Stands (S/R STANDS) | milestone | 0d | 2012-05-01 | 2012-05-01 | 9-120M FS+141d, 13414017 | 20d | 0d |  |  | BEVINS M | 1 | 1 |  | MIKE B |  | 10-030 | 10-065 | 11-057 | 12-035F | 12-039 | 6 |  |  |  |
| 13414025A |  | Vend Fab Stands Peg Point #1 Receipt of Material |  | 64d | 2012-05-01 | 2012-07-31 | 13414020M | 20d | 0d | PROCUREMENT<$50K 60 NO ESCALATION; PROCUREMENT>$50K 69 NO ESCALATION | 269,669.11 | BEVINS M | 1 | 1 |  | MIKE B |  | 10-030 | 10-065 | 11-057 | 12-035 | 12-039 |  |  |  |  |
| 13414025B |  | Vend Fab Stands Peg Point #2 Receipt and Acceptance of Finished Stands 002-015 (Qty 14) |  | 87d | 2012-05-01 | 2012-08-31 | 13414025A FS-64d | 20d | 0d | PROCUREMENT>$50K 69 NO ESCALATION | 123,397.68 | BEVINS M | 1 | 1 |  | MIKE B |  |  |  |  |  | 12-039 |  |  |  |  |
| 13414025C |  | Vend Fab Stands Peg Point #3 Receipt and Acceptance of Finished Stands 016-029 (Qty 14) |  | 106d | 2012-05-01 | 2012-09-28 | 13414025B FS-87d | 20d | 0d | PROCUREMENT>$50K 69 NO ESCALATION | 128,457.55 | BEVINS M | 1 | 1 |  | MIKE B |  |  |  |  |  | 12-039 |  |  |  |  |
| 13414025D |  | Vend Fab Stands Peg Point #4 Receipt and Acceptance of Finished Stands 030-040 (Qty 11) |  | 129d | 2012-05-01 | 2012-10-31 | 13414025C FS-106d | 20d | 0d | PROCUREMENT>$50K 69 NO ESCALATION | 100,931.05 | BEVINS M | 1 | 1 |  | MIKE B |  |  |  |  |  | 12-039 |  |  |  |  |
| 13414025F |  | Vend Fab Stands Peg Point #5 Receipt and Acceptance of Finished Stands 041-051 (Qty 11) |  | 149d | 2012-05-01 | 2012-11-30 | 13414025D FS-129d | 20d | 0d | PROCUREMENT>$50K 69 NO ESCALATION | 108,182.61 | BEVINS M | 1 | 1 |  | MIKE B |  |  |  |  |  | 12-039 |  |  |  |  |
| 13414025G |  | Vend Fab Stands Peg Point #6 Receipt and Acceptance of Finished Stands 052-071 (Qty 20) |  | 165d | 2012-05-01 | 2012-12-31 | 13414025F FS-149d | 20d | 0d | PROCUREMENT>$50K 69 NO ESCALATION | 168,259 | BEVINS M | 1 | 1 |  | MIKE B |  |  |  |  |  | 12-039 |  |  |  |  |
| 13414092 |  | Receive and Inspect S/R Brackets (S/R Stands) Revised Per CR 12-035 |  | 36d | 2012-07-16 | 2012-09-04 | 13414075 FS-54d | 20d | 0d | MECH TECH [240 h]; MECH ENG [60 h]; MECH DES [80 h] | 18,726.4 | BEVINS M | 1 | 1 |  | MIKE B |  | 10-030 | 10-065 | 11-057 | 12-035 |  |  |  |  |  |
| 13414029 |  | Receive and Inspect to S/R Stands Revised Per CR 12-035 FY12 |  | 31d | 2012-08-16 | 2012-09-28 | 13414025A, 13414025G FS-90d | 20d | 0d | MECH TECH [167.19 h]; MECH ENG [27.87 h]; MECH DES [13.93 h] | 10,055.17 | BEVINS M | 1 | 1 |  | MIKE B |  | 10-030 | 10-065 | 11-057 | 12-035 |  |  | 12-053 |  |  |
| 13414095M |  | Delivery Complete for S/R Cartridges & Brackets (S/R Stands) | milestone | 0d | 2012-09-04 | 2012-09-04 | 13414092, 13414070LOE, 13414090 | 20d |  |  |  | BEVINS M | 1 | 1 |  | MIKE B |  | 10-030 | 10-065 | 11-057 | 12-035 |  | 6 |  |  |  |
| 13414029a |  | Receive and Inspect to S/R Stands Revised Per CR 12-035 FY13 |  | 58d | 2012-10-01 | 2012-12-21 | 13414029 | 20d | 0d | MECH TECH [312.81 h]; MECH ENG [52.13 h]; MECH DES [26.07 h] | 19,413.54 | BEVINS M | 1 | 1 |  | MIKE B |  | 10-030 | 10-065 | 11-057 | 12-035 |  |  | 12-053 |  |  |
| 13414030M |  | Delivery Complete for New S/R Stands (S/R STANDS) | milestone | 0d | 2012-12-21 | 2012-12-21 | 13414022LOE, 13414025A FS-10d, 13414027, 13414029a | 20d |  |  |  | BEVINS M | 1 | 1 |  | MIKE B |  | 10-030 | 10-065 | 11-057 | 12-035 |  | 6 |  |  |  |
| 13414105 |  | Re-Baseline Actuals Adjustment |  | 1d | 2013-08-30 | 2013-08-30 | 9-130M FS+227d | 20d |  | PROCUREMENT>$50K 69 NO ESCALATION | 462,300.33 | BEVINS M | 1 | 1 |  | MIKE B |  |  |  |  |  |  |  |  | 13-014 | ADJ |

| ID | WBS | Activity | Type | Duration | Start | Finish | Predecessors | Total float | Free float | Calendar | Resources | Cost | RESP - Responsibility | STRT%COMP for CM EVM | FNSH%COMP for CM EVM | CAM RESPONSIBLE | CR 09-034 | CR 10-030 | CR 10-065 | CR 11-057 | Profile change | CR 08-016 | CR 09-012 | CR 11-041 | CR 07-024 | Duplications | CR 11-001 | CR 12-035 | Milestone Level | CR 13-014 | ReBaseline Actuals Adjustment | CR 13-003 | CR 12-053 | Original Activity ID Rebaseline | EVMS Reporting Codes | BOE Labor | CR 13-015 | Post Rebaseline | BOE Expenses | Over Under Fixed | Obligated Prior to Rebaseline | CR 14-001 |
| --- | --- | --- | --- | --- | --- | --- | --- | --- | --- | --- | --- | --- | --- | --- | --- | --- | --- | --- | --- | --- | --- | --- | --- | --- | --- | --- | --- | --- | --- | --- | --- | --- | --- | --- | --- | --- | --- | --- | --- | --- | --- | --- |
|  | 5 | **1.3.4.1.5 GIRDERS** |  |  |  |  |  |  |  |  |  |  |  |  |  |  |  |  |  |  |  |  |  |  |  |  |  |  |  |  |  |  |  |  |  |  |  |  |  |  |  |  |
|  | 6 | **1.3.4.1.6 VACUUM** |  |  | 2010-01-05 | 2013-08-30 |  |  |  |  |  |  |  |  |  |  |  |  |  |  |  |  |  |  |  |  |  |  |  |  |  |  |  |  |  |  |  |  |  |  |  |  |
| 13416020 |  | Prcrmnt Prep of S/R Dipole Chambers (S/R Vac) Initial |  | 60d | 2010-01-05 | 2010-03-31 | 121416010, 9-100M FS+60d, 121416000a, 121416005a | 415d | 406d |  | MECH DES [32 h]; MECH ENG [160 h] | 11,983.68 | BEVINS M | 1 | 1 | MIKE B | 09-034 | 10-030 | 10-065 | 11-057 |  |  |  |  |  |  |  |  |  |  |  |  |  |  |  |  |  |  |  |  |  |  |
| 13416040 |  | Procurement Prep of S/R Septa Chambers (S/R Vac) |  | 45d | 2010-03-01 | 2010-04-30 | 9-100M FS+97d | 313d | 0d |  | MECH DES [480 h]; MECH ENG [240 h] | 37,519.2 | BEVINS M | 1 | 1 | MIKE B |  | 10-030 | 10-065 |  | C | 08-016 | 09-012 | 11-041 |  |  |  |  |  |  |  |  |  |  |  |  |  |  |  |  |  |  |
| 13416042LOE |  | Vend Fab S/R Septa Chambers (S/R Vac) Oversight |  | 107d | 2010-04-22 | 2010-09-22 | 13416040 FS-7d | 431d | 118d |  | MECH DES [40 h]; MECH ENG [40 h] | 4,443.6 | BEVINS M | 1 | 1 | MIKE B |  | 10-030 | 10-065 |  |  |  |  | 11-041 |  |  |  |  |  |  |  |  |  |  |  |  |  |  |  |  |  |  |
| 13416045 |  | Vend Fab S/R Septa Chambers- ZAs (S/R Vac) ORG |  | 49d | 2010-04-22 | 2010-06-30 | 13416040 FS-7d | 313d | 0d |  | MSHOP | 36,635.51 | BEVINS M | 1 | 1 | MIKE B |  | 10-030 | 10-065 |  |  |  | 09-012 | 11-041 | 07-024 | DUP |  |  |  |  |  |  |  |  |  |  |  |  |  |  |  |  |
| 13416046 |  | Vend Fab S/R Septa Chambers- YRs (S/R Vac) ORG |  | 20d | 2010-06-03 | 2010-06-30 | 13416045 FS-20d | 313d | 0d |  | MSHOP | 4,615.38 | BEVINS M | 1 | 1 | MIKE B |  | 10-030 | 10-065 |  |  |  |  | 11-041 |  | DUP |  |  |  |  |  |  |  |  |  |  |  |  |  |  |  |  |
| 13416045a |  | Vend Fab S/R Septa Chambers- ZAs (S/R Vac) REDESIGN FY10 |  | 21d | 2010-09-01 | 2010-09-30 | 13416045 FS+43d | 368d | 0d |  | MSHOP | 11,675.05 | BEVINS M | 1 | 1 | MIKE B |  |  | 10-065 |  |  |  |  | 11-041 |  | DUP | 11-001 |  |  |  |  |  |  |  |  |  |  |  |  |  |  |  |
| 13416025 |  | Prcrmnt Prep of S/R Dipole Chambers (S/R Vac) Final |  | 110d | 2010-10-01 | 2011-03-17 | 9-110M | 177d | 168d |  | MECH DES [800 h]; MECH ENG [320 h] | 59,088 | BEVINS M | 1 | 1 | MIKE B |  | 10-030 | 10-065 | 11-057 |  |  |  |  |  |  |  |  |  |  |  |  |  |  |  |  |  |  |  |  |  |  |
| 13416045ab |  | Vend Fab S/R Septa Chambers- ZAs (S/R Vac) REDESIGN FY11 |  | 57d | 2010-10-01 | 2010-12-29 | 13416045a | 368d | 55d |  | MSHOP | 32,700.33 | BEVINS M | 1 | 1 | MIKE B |  |  | 10-065 |  |  |  |  | 11-041 |  | DUP | 11-001 |  |  |  |  |  |  |  |  |  |  |  |  |  |  |  |
| 13416049A |  | Vend Fab New Bellows (S/R Vac) |  | 110d | 2010-10-01 | 2011-03-17 | 9-110M | 288d |  |  | PROCUREMENT<$50K 60 | 22,677.03 | BEVINS M | 1 | 1 | MIKE B |  | 10-030 | 10-065 |  |  |  |  |  |  | DUP |  | 12-035F |  |  |  |  |  |  |  |  |  |  |  |  |  |  |
| 13416049B |  | Proc Vac Materials Flanges/Gaskets/Hardware (S/R Vac) |  | 110d | 2010-10-01 | 2011-03-17 | 9-110M | 288d |  |  | PROCUREMENT<$50K 60 | 26,078.18 | BEVINS M | 1 | 1 | MIKE B |  | 10-030 | 10-065 |  |  |  |  |  |  | DUP |  | 12-035F |  |  |  |  |  |  |  |  |  |  |  |  |  |  |
| 13416046a |  | Vend Fab S/R Septa Chambers- YRs (S/R Vac) REDESIGN |  | 91d | 2010-11-01 | 2011-03-21 | 13416046 FS+85d | 313d | 0d |  | MSHOP | 13,811.59 | BEVINS M | 1 | 1 | MIKE B |  |  | 10-065 |  |  |  |  | 11-041 |  | DUP |  |  |  |  |  |  |  |  |  |  |  |  |  |  |  |  |
| 13416047 |  | Vend Fab S/R Septa Chambers- YB (S/R Vac) |  | 91d | 2010-11-01 | 2011-03-21 | 13416046 FS+85d | 313d | 0d |  | MSHOP | 5,159.5 | BEVINS M | 1 | 1 | MIKE B |  | 10-030 | 10-065 |  |  |  |  | 11-041 |  | DUP |  |  |  |  |  |  |  |  |  |  |  |  |  |  |  |  |
| 13416048M |  | Fabrication Complete S/R Septa Chambers (S/R Vac) | milestone | 0d | 2011-03-21 | 2011-03-21 | 13416047, 13416046a, 13416046, 13416045ab, 13416045, 13416042LOE | 313d | 301d |  |  |  | BEVINS M | 1 | 1 | MIKE B |  | 10-030 | 10-065 |  |  |  |  | 11-041 |  |  |  |  | 6 |  |  |  |  |  |  |  |  |  |  |  |  |  |
| 13416025M |  | Award Contract for S/R Dipole Chambers (S/R VACUUM) | milestone | 0d | 2011-11-14 | 2011-11-14 | 13416020, 9-120M FS+30d, 13416025 | 9d | 0d |  |  |  | BEVINS M | 1 | 1 | MIKE B | 09-034 | 10-030 | 10-065 | 11-057 |  |  |  |  |  |  |  |  | 6 |  |  |  |  |  |  |  |  |  |  |  |  |  |
| 13416030 |  | Vend Fab S/R Dipole Chambers (S/R Vac) |  | 111d | 2011-11-14 | 2012-04-30 | 13416025M | 9d | 0d |  | PROCUREMENT<$50K 60; PROCUREMENT>$50K 69 | 74,537.23 | BEVINS M | 1 | 1 | MIKE B | 09-034 | 10-030 | 10-065 | 11-057 |  |  |  |  |  |  |  |  |  |  |  |  |  |  |  |  |  |  |  |  |  |  |
| 13416049 |  | Vend Fab New Drift Tubes (S/R Vac) |  | 138d | 2012-02-15 | 2012-08-29 | 9-120M FS+88d | 258d |  |  | PROCUREMENT<$50K 60 | 70,125.12 | BEVINS M | 1 | 1 | MIKE B |  | 10-030 |  | 11-057 |  |  |  |  |  |  |  | 12-035 |  |  |  |  |  |  |  |  |  |  |  |  |  |  |
| 13416032 |  | Receive and Inspect S/R Dipole Chambers (S/R Vac) |  | 10d | 2012-04-17 | 2012-04-30 | 13416030 FS-10d | 9d | 0d |  | MECH ENG [60 h]; MECH TECH [80 h] | 7,762.4 | BEVINS M | 1 | 1 | MIKE B |  | 10-030 | 10-065 | 11-057 |  |  |  |  |  |  |  |  |  |  |  |  |  |  |  |  |  |  |  |  |  |  |
| 13416035M |  | Delivery Complete for S/R Dipole Chambers (S/R VACUUM) | milestone | 0d | 2012-04-30 | 2012-04-30 | 13416030, 13416032 | 9d |  |  |  |  | BEVINS M | 1 | 1 | MIKE B | 09-034 | 10-030 | 10-065 | 11-057 |  |  |  |  |  |  |  |  | 6 |  |  |  |  |  |  |  |  |  |  |  |  |  |
| 13416050 |  | Re-Baseline Actuals Adjustment |  | 1d | 2013-08-30 | 2013-08-30 | 9-130M FS+227d | 20d |  |  | PROCUREMENT>$50K 69 NO ESCALATION | 238,648.55 | BEVINS M | 1 | 1 | MIKE B |  |  |  |  |  |  |  |  |  |  |  |  |  | 13-014 | ADJ |  |  |  |  |  |  |  |  |  |  |  |
|  | 7 | **1.3.4.1.7 INSTALLATION** |  |  | 2011-11-14 | 2013-11-11 |  |  |  |  |  |  |  |  |  |  |  |  |  |  |  |  |  |  |  |  |  |  |  |  |  |  |  |  |  |  |  |  |  |  |  |  |
| 13417015 |  | Accelerator Down Planning Activity |  | 115d | 2011-11-14 | 2012-05-04 | 4A-04M | 5d |  |  | MECH ENG [2000 h]; MECH TECH [1000 h] | 184,680 | BEVINS M | 1 | 1 | MIKE B |  |  | 10-065 |  |  |  |  |  |  |  |  |  |  |  |  |  |  |  |  |  |  |  |  |  |  |  |
| 13417155 |  | LCW Hoses FY12 |  | 127d | 2012-04-02 | 2012-09-28 | 9-120M FS+120d | 58d | 0d |  | PROCUREMENT<$50K 60; PROCUREMENT>$50K 69 | 85,000 | BEVINS M | 1 | 1 | MIKE B |  |  |  |  |  |  |  |  |  |  |  | 12-035 |  |  |  | 13-003F |  |  |  |  |  |  |  |  |  |  |
| 13417165 |  | Material handling/tooling/transporation FY12 |  | 127d | 2012-04-02 | 2012-09-28 | 9-120M FS+120d | 9d | 0d |  | PROCUREMENT<$50K 60 | 50,000 | BEVINS M | 1 | 1 | MIKE B |  |  |  |  |  |  |  |  |  |  |  | 12-035 |  |  |  |  |  |  |  |  |  |  |  |  |  |  |
| 13417035 |  | ER - Upstairs |  | 47d | 2012-06-05 | 2012-08-08 | 13417026M FS-18d | 273d |  |  | MECH TECH [1096 h]; MSHOP; MECH ENG [792 h] | 136,949.28 | BEVINS M | 1 | 1 | MIKE B |  |  | 10-065 |  |  |  | 09-012 |  | 07-024 | DUP |  | 12-035 |  |  |  |  |  |  |  |  |  |  |  |  |  |  |
| 13417020 |  | Re-survey align network |  | 10d | 2012-06-18 | 2012-06-29 | 13411137, 13411139 FS-55d, 13414100, 2-02M FS+23d, 13411175, 13411195, 13411135ab, 3A-19M, 13411135b, 13411190 | 284d | 154d |  | MECH TECH [400 h]; MECH ENG [288 h] | 37,970.56 | BEVINS M | 1 | 1 | MIKE B |  |  | 10-065 |  |  |  |  |  |  |  |  | 12-035 |  |  |  |  |  |  |  |  |  |  |  |  |  |  |
| 13417030 |  | ER - Install stands |  | 54d | 2012-06-27 | 2012-09-11 | 13417026M FS-2d | 63d | 0d |  | MECH TECH [896 h]; MECH ENG [648 h] | 85,256 | BEVINS M | 1 | 1 | MIKE B |  |  | 10-065 |  |  |  | 09-012 |  | 07-024 | DUP |  | 12-035 |  |  |  |  |  |  |  |  |  |  |  |  |  |  |
| 13417026M |  | ER - Removed (BIA Activity Complete) | milestone | 0d | 2012-06-28 | 2012-06-28 | 2-02M FS+32d | 63d | 0d |  |  |  | BEVINS M | 1 | 1 | MIKE B |  |  | 10-065 |  |  |  | 09-012 |  | 07-024 | DUP |  | 12-035 |  |  |  |  |  |  |  |  |  |  |  |  |  |  |
| 13417060 |  | WR - Upstairs FY12 |  | 64d | 2012-07-02 | 2012-09-28 | 13417050M FS-48d | 140d | 0d |  | MSHOP; MECH ENG [708.64 h]; MECH TECH [1031.42 h] | 122,977.5 | BEVINS M | 1 | 1 | MIKE B |  |  |  |  |  |  |  |  |  |  |  | 12-035 |  |  |  |  | 12-053 |  |  |  |  |  |  |  |  |  |
| 13417085 |  | ES - Upstairs FY12 |  | 49d | 2012-07-23 | 2012-09-28 | 13417075M FS-37d | 75d | 0d |  | MECH TECH [500.43 h]; MSHOP; MECH ENG [241.87 h] | 54,025.18 | BEVINS M | 1 | 1 | MIKE B |  |  |  |  |  |  |  |  |  |  |  | 12-035 |  |  |  |  | 12-053 |  |  |  |  |  |  |  |  |  |
| 13417050M |  | WR - Removed (BIA Activity Complete) | milestone | 0d | 2012-09-06 | 2012-09-06 | 2-02M FS+81d | 78d | 0d |  |  |  | BEVINS M | 1 | 1 | MIKE B |  |  |  |  |  |  |  |  |  |  |  | 12-035 |  |  |  |  |  |  |  |  |  |  |  |  |  |  |
| 13417075M |  | ES - Removed (BIA Activity Complete) | milestone | 0d | 2012-09-12 | 2012-09-12 | 2-02M FS+85d | 75d | 0d |  |  |  | BEVINS M | 1 | 1 | MIKE B |  |  |  |  |  |  |  |  |  |  |  | 12-035 |  |  |  |  |  |  |  |  |  |  |  |  |  |  |
| 13417080 |  | ES - Install stands FY12 |  | 12d | 2012-09-13 | 2012-09-28 | 13417075M | 163d | 0d |  | MECH TECH [354.46 h]; MECH ENG [160.62 h] | 27,014.87 | BEVINS M | 1 | 1 | MIKE B |  |  |  |  |  |  |  |  |  |  |  | 12-035 |  |  |  |  | 12-053 |  |  |  |  |  |  |  |  |  |
| 13417040 |  | ER - Install magnets and girders FY12 |  | 9d | 2012-09-18 | 2012-09-28 | 13417030 FS+4d | 63d | 0d |  | MECH TECH [242.53 h]; MECH ENG [68.68 h] | 15,593.87 | BEVINS M | 1 | 1 | MIKE B |  |  | 10-065 |  |  | 08-016 | 09-012 |  |  |  |  | 12-035 |  |  |  |  | 12-053 |  |  |  |  |  |  |  |  |  |
| 13417040a |  | ER - Install magnets and girders FY13 |  | 67d | 2012-10-01 | 2013-01-11 | 13417040 | 63d | 5d |  | MECH ENG [511.32 h]; MECH TECH [1805.47 h] | 119,797.97 | BEVINS M | 1 | 1 | MIKE B |  |  | 10-065 |  |  | 08-016 | 09-012 |  |  |  |  | 12-035 |  |  |  |  | 12-053 |  |  |  |  |  |  |  |  |  |
| 13417060a |  | WR - Upstairs FY13 |  | 5d | 2012-10-01 | 2012-10-05 | 13417060 | 140d | 62d |  | MECH TECH [80.58 h]; MSHOP; MECH ENG [55.36 h] | 9,914.3 | BEVINS M | 1 | 1 | MIKE B |  |  |  |  |  |  |  |  |  |  |  | 12-035 |  |  |  |  | 12-053 |  |  |  |  |  |  |  |  |  |
| 13417080a |  | ES - Install stands FY13 |  | 14d | 2012-10-01 | 2012-10-18 | 13417080 | 163d | 88d |  | MECH TECH [413.54 h]; MECH ENG [187.38 h] | 32,523.76 | BEVINS M | 1 | 1 | MIKE B |  |  |  |  |  |  |  |  |  |  |  | 12-035 |  |  |  |  | 12-053 |  |  |  |  |  |  |  |  |  |
| 13417085a |  | ES - Upstairs FY13 |  | 45d | 2012-10-01 | 2012-12-04 | 13417085 | 75d | 0d |  | MECH TECH [459.57 h]; MSHOP; MECH ENG [222.13 h] | 51,199.41 | BEVINS M | 1 | 1 | MIKE B |  |  |  |  |  |  |  |  |  |  |  | 12-035 |  |  |  |  | 12-053 |  |  |  |  |  |  |  |  |  |
| 13417160 |  | LCW Hoses FY13 |  | 120d | 2012-10-01 | 2013-03-29 | 13417155 | 58d | 0d |  | PROCUREMENT<$50K 60; PROCUREMENT>$50K 69 | 160,000 | BEVINS M | 1 | 1 | MIKE B |  |  |  |  |  |  |  |  |  |  |  | 12-035 |  |  |  | 13-003 |  |  |  |  |  |  |  |  |  |  |
| 13417170 |  | Material handling/tooling/transporation FY13 |  | 228d | 2012-10-01 | 2013-08-30 | 13417165 | 9d |  |  | PROCUREMENT<$50K 60 | 36,116.5 | BEVINS M | 1 | 1 | MIKE B |  |  |  |  |  |  |  |  |  |  |  | 12-035 |  |  |  |  |  |  |  |  |  |  |  |  |  |  |
| 13417110 |  | WS - Upstairs |  | 66d | 2012-10-26 | 2013-02-07 | 13417100M FS-14d | 24d | 0d |  | MECH TECH [1000 h]; MSHOP; MECH ENG [224 h] | 92,517.95 | BEVINS M | 1 | 1 | MIKE B |  |  |  |  |  |  |  |  |  |  |  | 12-035 |  |  |  |  |  |  |  |  |  |  |  |  |  |  |
| 13417100M |  | WS - Removed (BIA Activity Complete) | milestone | 0d | 2012-11-14 | 2012-11-14 | 2-02M FS+130d | 24d | 0d |  |  |  | BEVINS M | 1 | 1 | MIKE B |  |  |  |  |  |  |  |  |  |  |  | 12-035 |  |  |  |  |  |  |  |  |  |  |  |  |  |  |
| 13417105 |  | WS - Install stands |  | 21d | 2012-11-15 | 2012-12-17 | 13417100M | 55d | 31d |  | MECH TECH [752 h]; MECH ENG [168 h] | 46,643.2 | BEVINS M | 1 | 1 | MIKE B |  |  |  |  |  |  |  |  |  |  |  | 12-035 |  |  |  |  |  |  |  |  |  |  |  |  |  |  |
| 13417055 |  | WR - Install stands |  | 31d | 2012-11-20 | 2013-01-11 | 13447035 | 78d | 0d |  | MECH TECH [936 h]; MECH ENG [208 h] | 57,975.84 | BEVINS M | 1 | 1 | MIKE B |  |  |  |  |  |  |  |  |  |  |  | 12-035 |  |  |  |  |  |  |  |  |  |  |  |  |  |  |
| 13417065 |  | WR - Install magnets & girders |  | 65d | 2013-01-14 | 2013-04-16 | 13417060a, 13417055 | 78d | 54d |  | MECH TECH [2104 h]; MECH ENG [472 h] | 130,643.36 | BEVINS M | 1 | 1 | MIKE B |  |  |  |  |  |  |  |  |  |  |  | 12-035 |  |  |  |  |  |  |  |  |  |  |  |  |  |  |
| 13417115 |  | WS - Install magnets and girders |  | 86d | 2013-02-08 | 2013-06-11 | 13417110, 13417105 | 24d | 0d |  | MECH TECH [1544 h]; MECH ENG [344 h] | 95,699.68 | BEVINS M | 1 | 1 | MIKE B |  |  |  |  |  |  |  |  |  |  |  | 12-035 |  |  |  |  |  |  |  |  |  |  |  |  |  |  |
| 13417135 |  | TR - Upstairs |  | 41d | 2013-02-19 | 2013-04-16 | 13417125M FS-11d | 46d | 0d |  | MECH TECH [912 h]; MSHOP; MECH ENG [204 h] | 84,466.67 | BEVINS M | 1 | 1 | MIKE B |  |  |  |  |  |  |  |  |  |  |  | 12-035 |  |  |  |  |  |  |  |  |  |  |  |  |  |  |
| 13417125M |  | TR - Removed (BIA Activity Complete) | milestone | 0d | 2013-03-05 | 2013-03-05 | 2-02M FS+199d | 46d | 0d |  |  |  | BEVINS M | 1 | 1 | MIKE B |  |  |  |  |  |  |  |  |  |  |  | 12-035 |  |  |  |  |  |  |  |  |  |  |  |  |  |  |
| 13417090 |  | ES - Install magnets & girders |  | 50d | 2013-03-06 | 2013-05-14 | 13417080a, 13417085a FS+57d | 75d | 51d |  | MECH ENG [344 h]; MECH TECH [1528 h] | 94,965.92 | BEVINS M | 1 | 1 | MIKE B |  |  |  |  |  |  |  |  |  |  |  | 12-035 |  |  |  |  |  |  |  |  |  |  |  |  |  |  |
| 13417130 |  | TR - Install stands |  | 22d | 2013-03-06 | 2013-04-04 | 13417125M | 59d | 13d |  | MECH TECH [752 h]; MECH ENG [168 h] | 46,643.2 | BEVINS M | 1 | 1 | MIKE B |  |  |  |  |  |  |  |  |  |  |  | 12-035 |  |  |  |  |  |  |  |  |  |  |  |  |  |  |
| 13417045 |  | ER - Final align |  | 8d | 2013-04-01 | 2013-04-10 | 13417040a FS+48d, 13417160 | 58d | 0d |  | MECH TECH [304 h]; MECH ENG [68 h] | 18,861.92 | BEVINS M | 1 | 1 | MIKE B |  |  |  |  |  |  |  |  |  |  |  | 12-035 |  |  |  | 13-003 |  |  |  |  |  |  |  |  |  |  |
| 13417140 |  | TR - Install magnets and girders |  | 47d | 2013-04-24 | 2013-06-28 | 13417130, 13417135 FS+5d | 46d | 0d |  | MECH TECH [1536 h]; MECH ENG [344 h] | 95,332.8 | BEVINS M | 1 | 1 | MIKE B |  |  |  |  |  |  |  |  |  |  |  | 12-035 |  |  |  |  |  |  |  |  |  |  |  |  |  |  |
| 13417120 |  | WS - Final align |  | 5d | 2013-06-12 | 2013-06-18 | 13417115, 13436060 | 24d | 0d |  | MECH ENG [44 h]; MECH TECH [200 h] | 12,355.84 | BEVINS M | 1 | 1 | MIKE B |  |  |  |  |  |  |  |  |  |  |  | 12-035 |  |  |  |  |  |  |  |  |  |  |  |  |  |  |
| 13417145 |  | TR - Final align |  | 4d | 2013-07-01 | 2013-07-05 | 13417140 | 46d | 22d |  | MECH TECH [100 h]; MECH ENG [24 h] | 6,322.64 | BEVINS M | 1 | 1 | MIKE B |  |  |  |  |  |  |  |  |  |  |  | 12-035 |  |  |  |  |  |  |  |  |  |  |  |  |  |  |
| 13417070 |  | WR - Final align |  | 8d | 2013-07-03 | 2013-07-15 | 13417065, 13427062 | 24d | 0d |  | MECH TECH [320 h]; MECH ENG [72 h] | 19,885.12 | BEVINS M | 1 | 1 | MIKE B |  |  |  |  |  |  |  |  |  |  |  | 12-035 |  |  |  |  |  |  |  |  |  |  |  |  |  |  |
| 13417095 |  | ES - Final align |  | 5d | 2013-07-29 | 2013-08-02 | 13436065, 13417090 | 24d | 0d |  | MECH TECH [200 h]; MECH ENG [44 h] | 12,355.84 | BEVINS M | 1 | 1 | MIKE B |  |  |  |  |  |  |  |  |  |  |  | 12-035 |  |  |  |  |  |  |  |  |  |  |  |  |  |  |
| 13417150 |  | Alignment complete |  | 3d | 2013-08-07 | 2013-08-09 | 13427061, 13417145, 13427032 | 24d |  |  | MECH TECH [60 h]; MECH ENG [12 h] | 3,619.92 | BEVINS M | 1 | 1 | MIKE B |  |  |  |  |  |  |  |  |  |  |  | 12-035 |  |  |  |  |  |  |  |  |  |  |  |  |  |  |
| 13417175 |  | Re-Baseline Actuals Adjustment |  | 1d | 2013-08-30 | 2013-08-30 | 9-130M FS+227d | 20d |  |  | PROCUREMENT>$50K 69 NO ESCALATION | 1,070,381.23 | BEVINS M | 1 | 1 | MIKE B |  |  |  |  |  |  |  |  |  |  |  |  |  | 13-014 | ADJ |  |  |  |  |  |  |  |  |  |  |  |
| 23417065 |  | WR - Install magnets & girders |  | 20d | 2013-09-03 | 2013-09-30 | 9-130M FS+228d | 4d |  | 8/5 M-F w/JLAB Holidays ReBaseline | MECH TECH [118.2 h]; MECH ENG [28.34 h] | 7,471.36 | BEVINS M | 1 | 1 | MIKE B |  |  |  |  |  |  |  |  |  |  |  | 12-035 |  |  |  |  |  | 23417065 | H | PE | 13-015 | PR |  |  |  |  |
| 23417115 |  | WS - Install magnets and girders |  | 11d | 2013-09-03 | 2013-09-17 | 9-130M FS+228d | 27d | 0d | 8/5 M-F w/JLAB Holidays ReBaseline | MECH TECH [153.07 h]; MECH ENG [36 h] | 9,624.74 | BEVINS M | 1 | 1 | MIKE B |  |  |  |  |  |  |  |  |  |  |  | 12-035 |  |  |  |  |  | 23417115 | H | PE | 13-015 | PR |  |  |  |  |
| 23417120 |  | WS - Final align |  | 13d | 2013-09-03 | 2013-09-19 | 23417115 FS-11d | 27d | 25d | 8/5 M-F w/JLAB Holidays ReBaseline | MECH TECH [211.2 h]; MECH ENG [52.8 h] | 13,506.24 | BEVINS M | 1 | 1 | MIKE B |  |  |  |  |  |  |  |  |  |  |  | 12-035 |  |  |  |  |  | 23417120 | S | PE | 13-015 | PR |  |  |  |  |
| 23417130 |  | TR - Install stands |  | 16d | 2013-09-03 | 2013-09-24 | 9-130M FS+228d | 4d | 0d | 8/5 M-F w/JLAB Holidays ReBaseline | MECH TECH [280.8 h]; MECH ENG [70.2 h] | 17,957.16 | BEVINS M | 1 | 1 | MIKE B |  |  |  |  |  |  |  |  |  |  |  | 12-035 |  |  |  |  |  | 23417130 | S | PE | 13-015 | PR |  |  |  |  |
| 23417140 |  | TR - Install magnets and girders FY13 |  | 20d | 2013-09-03 | 2013-09-30 | 23417130 FS-16d | 4d | 0d | 8/5 M-F w/JLAB Holidays ReBaseline | MECH TECH [616.32 h]; MECH ENG [148.8 h] | 39,031.61 | BEVINS M | 1 | 1 | MIKE B |  |  |  |  |  |  |  |  |  |  |  | 12-035 |  |  |  |  |  | 23417140 | S | PE | 13-015 | PR |  |  |  |  |
| 23417165 |  | Procure S/R plumbing materials |  | 20d | 2013-09-03 | 2013-09-30 | 9-130M FS+228d | 4d |  | 8/5 M-F w/JLAB Holidays ReBaseline | SUPPLIES & MATERIALS | 12,255 | BEVINS M | 1 | 1 | MIKE B |  |  |  |  |  |  |  |  |  |  |  | 12-035 |  |  |  | 13-003 |  | 23417165 | D |  | 13-015 | PR | PE |  |  |  |
| 23417170 |  | Procure S/R Vacuum materials |  | 20d | 2013-09-03 | 2013-09-30 | 9-130M FS+228d | 4d |  | 8/5 M-F w/JLAB Holidays ReBaseline | PROCUREMENT<$50K 60 | 9,830.9 | BEVINS M | 1 | 1 | MIKE B |  |  |  |  |  |  |  |  |  |  |  | 12-035 |  |  |  | 13-003 |  | 23417165 | D |  | 13-015 | PR | PE | y | OB |  |
| 23417145 |  | TR - Final align FY13 |  | 1d | 2013-09-30 | 2013-09-30 | 23417140 FS-2d, 23417140a FS-2d | 4d | 0d | 8/5 M-F w/JLAB Holidays ReBaseline | MECH TECH [9.09 h]; MECH ENG [2.27 h] | 581.18 | BEVINS M | 1 | 1 | MIKE B |  |  |  |  |  |  |  |  |  |  |  | 12-035 |  |  |  |  |  | 23417145 | S | PE | 13-015 | PR |  |  |  |  |
| 23417140a |  | TR - Install magnets and girders FY14 |  | 1d | 2013-10-01 | 2013-10-01 | 23417140, 23417130 FS-16d | 4d | 0d | 8/5 M-F w/JLAB Holidays ReBaseline | MECH TECH [30.82 h]; MECH ENG [7.44 h] | 2,013.97 | BEVINS M | 1 | 1 | MIKE B |  |  |  |  |  |  |  |  |  |  |  | 12-035 |  |  |  |  |  | 23417140 | S | PE | 13-015 | PR |  |  |  | 14-001 |
| 23417145a |  | TR - Final align FY14 |  | 21d | 2013-10-01 | 2013-10-29 | 23417145, 23417140a FS-2d, 23417140 FS-2d | 4d | 0d | 8/5 M-F w/JLAB Holidays ReBaseline | MECH TECH [190.91 h]; MECH ENG [47.73 h] | 12,597.81 | BEVINS M | 1 | 1 | MIKE B |  |  |  |  |  |  |  |  |  |  |  | 12-035 |  |  |  |  |  | 23417145 | S | PE | 13-015 | PR |  |  |  | 14-001 |
| 23417150 |  | Alignment complete |  | 3d | 2013-11-07 | 2013-11-11 | 23417145a FS+6d, 23417145 FS+6d | 4d |  | 8/5 M-F w/JLAB Holidays ReBaseline | MECH TECH [64 h]; MECH ENG [16 h] | 4,223.2 | BEVINS M | 1 | 1 | MIKE B |  |  |  |  |  |  |  |  |  |  |  | 12-035 |  |  |  |  |  | 23417150 | H | PE | 13-015 | PR |  |  |  | 14-001 |

| ID | WBS | Activity | Type | Duration | Start | Finish | Predecessors | Total float | Free float | Resources | Cost | RESP - Responsibility | STRT%COMP for CM EVM | FNSH%COMP for CM EVM | CAM RESPONSIBLE | CR 08-029 | CR 08-058 | CR 10-065 | CR 07-024 | Advance Purchase Plan > 500K | CR 08-016 | CR 09-012 | CR 09-034 | CR 10-003 | CR 11-001 | Milestone Level | CR 08-010 | 12 GEV MAJOR PROCUREMENT CATAGORY | CR 10-030 | CR 13-014 | ReBaseline Actuals Adjustment |
| --- | --- | --- | --- | --- | --- | --- | --- | --- | --- | --- | --- | --- | --- | --- | --- | --- | --- | --- | --- | --- | --- | --- | --- | --- | --- | --- | --- | --- | --- | --- | --- |
|  | 2 | **1.3.4.2 EXISTING ARCS (1-9, A, B, & C)** |  |  | 2009-01-02 | 2013-11-18 |  |  |  |  |  |  |  |  |  |  |  |  |  |  |  |  |  |  |  |  |  |  |  |  |  |
|  | 1 | **1.3.4.2.1 DIPOLES** |  |  | 2009-01-02 | 2013-08-30 |  |  |  |  |  |  |  |  |  |  |  |  |  |  |  |  |  |  |  |  |  |  |  |  |  |
| 13421909LOE |  | FY09 Mngmnt & Oversight (EXIST ARC Dipoles) |  | 189d | 2009-01-02 | 2009-09-30 | 13421909LOEXD | 20d | 0d | SR STAFF [213.39 h]; TRAVEL | 39,529.9 | BEVINS M | 1 | 1 | MIKE B | 08-029 | 08-058 |  |  |  |  |  |  |  |  |  |  |  |  |  |  |
| 13421025 |  | Prcrmnt Prep for New Hall A&C Dipoles |  | 117d | 2009-01-12 | 2009-06-26 | 9-090M FS+65d | 321d | 0d | MECH ENG [44 h]; MECH DES [40 h] | 4,561.24 | BEVINS M | 1 | 1 | MIKE B | 08-029 |  | 10-065 |  |  |  |  |  |  |  |  |  |  |  |  |  |
| 13421046 |  | Fabrication of Existing Arc Dipole Rebuild Parts |  | 97d | 2009-01-12 | 2009-05-29 | 9-090M FS+65d | 89.54d | 0d | MECH TECH [72 h]; MECH ENG [72 h]; MECH DES [21 h] | 8,427.36 | BEVINS M | 1 | 1 | MIKE B | 08-029 |  |  | 07-024 | APP | 08-016 | 09-012 | 09-034 |  |  |  |  |  |  |  |  |
| 13421030 |  | Vendor Fab New Hall A&C Dipoles Original Labor FY10 |  | 314d | 2009-06-29 | 2010-09-30 | 13421025 | 321d | 0d | MECH DES [73.88 h]; MECH ENG [170.25 h] | 14,458.55 | BEVINS M | 1 | 1 | MIKE B | 08-029 |  | 10-065 |  |  |  | 09-012 |  | 10-003 | 11-001 |  |  |  |  |  |  |
| 13421050M |  | Delivery Complete for Magnet Steel & Conductor (EXIST ARC DIPOLES) | milestone | 0d | 2009-06-29 | 2009-06-29 | 13422040M FS-25d, 13411100M, 13411080M, 13411120M, 13451060M | 1361d |  |  |  | BEVINS M | 1 | 1 | MIKE B | 08-029 |  |  |  |  |  |  | 09-034 |  |  | 6 |  |  |  |  |  |
| 13421910LOE |  | FY10 Mngmnt & Oversight (EXIST ARC Dipoles) |  | 248d | 2009-10-01 | 2010-09-30 | 13421909LOE, 13444909LOE | 20d | 0d | TRAVEL; SR STAFF [320 h] | 57,769.07 | BEVINS M | 1 | 1 | MIKE B | 08-029 |  |  |  |  |  |  |  |  |  |  |  |  |  |  |  |
| 13421055 |  | Prcrmnt Prep for H Steel (EXIST ARC Dipoles) |  | 110d | 2009-10-05 | 2010-03-19 | 121425015, 121421021, 121421020, 13411055 FS-110d | 169d | 0d | MECH ENG [40 h]; MECH DES [20 h] | 3,538.8 | BEVINS M | 1 | 1 | MIKE B | 08-029 |  | 10-065 |  |  |  |  |  |  |  |  |  |  |  |  |  |
| 13421060M |  | Award Contract for H Steel (EXIST ARC DIPOLES) | milestone | 0d | 2010-03-22 | 2010-03-22 | 13421055 | 169d | 0d |  |  | BEVINS M | 1 | 1 | MIKE B | 08-029 |  | 10-065 |  |  |  |  |  |  |  | 6 |  |  |  |  |  |
| 13421065 |  | P-1 Vend Fab H Steel (EXIST ARC Dipoles) Labor FY10 |  | 136d | 2010-03-22 | 2010-09-30 | 13421060M | 169d | 0d | MECH DES [21.94 h]; MECH ENG [21.94 h] | 2,437.32 | BEVINS M | 1 | 1 | MIKE B | 08-029 |  | 10-065 |  | APP | 08-016 | 09-012 |  |  | 11-001 |  | 08-010 | 3421 | 10-030 |  |  |
| 13421065b |  | P-1 Vend Fab H Steel (EXIST ARC Dipoles) Procurement |  | 248d | 2010-03-22 | 2011-03-21 | 13421060M | 169d | 0d | PROCUREMENT<$50K 60 NO ESCALATION FY11; PROCUREMENT>$50K 69 NO ESCALATION FY11 | 380,788.36 | BEVINS M | 1 | 1 | MIKE B | 08-029 |  | 10-065 |  | APP | 08-016 | 09-012 |  |  | 11-001 |  | 08-010 | 3421 | 10-030 |  |  |
| 13421046a |  | Fabrication of Existing Arc Dipole Rebuild Parts (Labor) FY10 |  | 105d | 2010-05-03 | 2010-09-30 | 13421046 FS+228.46d | 89.54d | 0d | MECH DES [14.62 h]; MECH TECH [45.78 h]; MECH ENG [45.78 h] | 5,586.88 | BEVINS M | 1 | 1 | MIKE B | 08-029 |  |  | 07-024 | APP | 08-016 | 09-012 | 09-034 |  | 11-001 |  |  |  |  |  |  |
| 13421046b |  | Fabrication of Existing Arc Dipole Rebuild Parts (proc) |  | 166d | 2010-05-03 | 2011-01-05 | 13421046 FS+228.46d | 89.54d |  | PROCUREMENT>$50K 69 NO ESCALATION FY11; PROCUREMENT<$50K 60 NO ESCALATION FY11 | 374,815.8 | BEVINS M | 1 | 1 | MIKE B | 08-029 |  |  | 07-024 | APP | 08-016 | 09-012 | 09-034 |  |  |  |  |  |  |  |  |
| 13421085 |  | Vendor Fab and Delivery of Magnet Refurbishment Crane |  | 50d | 2010-09-13 | 2010-11-19 | 9-100M FS+234d | 54d | 0d | PROCUREMENT<$50K 60 NO ESCALATION FY11; PROCUREMENT>$50K 69 NO ESCALATION FY11 | 80,000 | BEVINS M | 1 | 1 | MIKE B |  |  | 10-065 |  |  |  |  |  |  |  |  |  |  |  |  |  |
| 13421046ab |  | Fabrication of Existing Arc Dipole Rebuild Parts (Labor) FY11 |  | 61d | 2010-09-30 | 2011-01-05 | 13421046a | 89.54d |  | MECH DES [8.38 h]; MECH TECH [26.22 h]; MECH ENG [26.22 h] | 3,301.22 | BEVINS M | 1 | 1 | MIKE B | 08-029 |  |  | 07-024 | APP | 08-016 | 09-012 | 09-034 |  | 11-001 |  |  |  |  |  |  |
| 13421030a |  | Vendor Fab New Hall A&C Dipoles Original Labor FY11 |  | 77d | 2010-10-01 | 2011-01-28 | 13421030 | 321d |  | MECH DES [18.12 h]; MECH ENG [41.75 h] | 3,682.75 | BEVINS M | 1 | 1 | MIKE B | 08-029 |  | 10-065 |  |  |  | 09-012 |  | 10-003 | 11-001 |  |  |  |  |  |  |
| 13421065a |  | P-1 Vend Fab H Steel (EXIST ARC Dipoles) Labor FY11 |  | 112d | 2010-10-01 | 2011-03-21 | 13421065 | 169d | 0d | MECH ENG [18.06 h]; MECH DES [18.06 h] | 2,070.22 | BEVINS M | 1 | 1 | MIKE B | 08-029 |  | 10-065 |  | APP | 08-016 | 09-012 |  |  | 11-001 |  | 08-010 | 3421 | 10-030 |  |  |
| 13421095 |  | Vend Fab Survey Instrument |  | 40d | 2010-10-01 | 2010-11-29 | 9-110M | 110d |  | MECH ENG [40 h]; PROCUREMENT<$50K 60; PROCUREMENT>$50K 69 | 183,300.5 | BEVINS M | 1 | 1 | MIKE B |  |  | 10-065 |  |  |  |  |  |  |  |  |  |  |  |  |  |
| 13421911LOE |  | FY11 Mngmnt & Oversight (EXIST ARC Dipoles) |  | 248d | 2010-10-01 | 2011-09-30 | 13421910LOE | 20d | 0d | SR STAFF [280 h]; TRAVEL | 54,065.19 | BEVINS M | 1 | 1 | MIKE B | 08-029 |  |  |  |  |  |  |  |  |  |  |  |  |  |  |  |
| 13421090 |  | Installation of Magnetic Refurbishment Crane |  | 60d | 2010-11-22 | 2011-02-25 | 13421085 | 54d |  | PROCUREMENT<$50K 60; MECH TECH [120 h]; PROCUREMENT>$50K 69 | 56,763.4 | BEVINS M | 1 | 1 | MIKE B |  |  | 10-065 |  |  |  |  |  |  |  |  |  |  |  |  |  |
| 13421066 |  | P-2 Vend Fab H Steel (EXIST ARC Dipoles) |  | 170d | 2011-01-04 | 2011-09-02 | 13421065a FS-53d, 13421065b FS-53d | 169d | 0d | PROCUREMENT>$50K 69; MECH ENG [20 h]; MECH DES [20 h]; PROCUREMENT<$50K 60 | 734,083.3 | BEVINS M | 1 | 1 | MIKE B | 08-029 |  | 10-065 |  | APP | 08-016 |  |  |  |  |  | 08-010 | 3421 | 10-030 |  |  |
| 13421067M |  | Delivery of First Article H Steel | milestone | 0d | 2011-02-22 | 2011-02-22 | 13421060M FS+229d | 305d | 136d |  |  | BEVINS M | 1 | 1 | MIKE B | 08-029 |  | 10-065 |  | APP | 08-016 |  |  |  |  |  | 08-010 |  |  |  |  |
| 13421070M |  | Delivery Complete for H Steel for S/R Dipoles (EXIST ARC DIPOLES) | milestone | 0d | 2011-09-02 | 2011-09-02 | 13421065b, 13421067M, 13421066, 13421065a | 169d |  |  |  | BEVINS M | 1 | 1 | MIKE B | 08-029 |  | 10-065 |  |  |  |  |  |  |  | 6 |  |  |  |  |  |
| 13421912LOE |  | FY12 Mngmnt & Oversight (EXIST ARC Dipoles) |  | 247d | 2011-10-03 | 2012-09-28 | 13421911LOE | 20d | 0d | SR STAFF [320 h]; TRAVEL | 61,280.03 | BEVINS M | 1 | 1 | MIKE B | 08-029 |  |  |  |  |  |  |  |  |  |  |  |  |  |  |  |
| 13421950 |  | Re-Baseline Actuals Adjustment |  | 1d | 2013-08-30 | 2013-08-30 | 9-130M FS+227d | 20d |  | PROCUREMENT>$50K 69 NO ESCALATION | 189,354.88 | BEVINS M | 1 | 1 | MIKE B |  |  |  |  |  |  |  |  |  |  |  |  |  |  | 13-014 | ADJ |

| ID | WBS | Activity | Type | Duration | Start | Finish | Predecessors | Total float | Free float | Resources | Cost | RESP - Responsibility | STRT%COMP for CM EVM | FNSH%COMP for CM EVM | CAM RESPONSIBLE | CR 08-029 | CR 08-058 | Advance Purchase Plan > 500K | CR 08-016 | CR 08-044 | CR 08-051 | 12 GEV MAJOR PROCUREMENT CATAGORY | CR 09-012 | CR 09-040 | CR 10-065 | CR 12-035 | CR 10-001 | Milestone Level | CR 11-001 | CR 10-030 | CR 11-057 | CR 12-018 | CR 12-029 | CR 12-001 | CR 13-014 | ReBaseline Actuals Adjustment |
| --- | --- | --- | --- | --- | --- | --- | --- | --- | --- | --- | --- | --- | --- | --- | --- | --- | --- | --- | --- | --- | --- | --- | --- | --- | --- | --- | --- | --- | --- | --- | --- | --- | --- | --- | --- | --- |
|  | 2 | **1.3.4.2.2 QUADRUPOLES** |  |  | 2009-01-02 | 2013-08-30 |  |  |  |  |  |  |  |  |  |  |  |  |  |  |  |  |  |  |  |  |  |  |  |  |  |  |  |  |  |  |
| 13422035 |  | Prcrmnt Prep for Quads (EXIST ARC Q-POLES) |  | 32d | 2009-01-02 | 2009-02-18 | 13422035XD | 1477d | 115d | MECH ENG [42.2 h]; MECH DES [28.13 h] | 3,926 | BEVINS M | 1 | 1 | MIKE B | 08-029 | 08-058 |  |  |  |  |  |  |  |  |  |  |  |  |  |  |  |  |  |  |  |
| 13422045 |  | Vend Fab Quads (EXIST ARC Q-POLES) LABOR Initial |  | 115d | 2009-02-19 | 2009-07-31 | 9-090M FS+91d | 576d | 0d | MECH DES [55.65 h]; MECH ENG [46.37 h] | 5,398.62 | BEVINS M | 1 | 1 | MIKE B | 08-029 |  | APP | 08-016 | 08-044 | 08-051 | 3422 | 09-012 | 09-040 | 10-065 | 12-035F |  |  |  |  |  |  |  |  |  |  |
| 13432004 |  | Procurement Prep for Linac Correctors FY09 |  | 63d | 2009-07-02 | 2009-09-30 | 9-090M FS+185d | 302d | 0d | MECH DES [21.72 h]; MECH ENG [21.72 h] | 2,338.15 | BEVINS M | 1 | 1 | MIKE B | 08-029 |  |  |  |  |  |  |  |  |  |  | 10-001B |  |  |  |  |  |  |  |  |  |
| 13422040M |  | Award Contract for Quadrupoles (EXIST ARC Q-POLES) | milestone | 0d | 2009-08-03 | 2009-08-03 | 9-090M FS+206d, 13422035, 1114010 | 1362d | 1d |  |  | BEVINS M | 1 | 1 | MIKE B | 08-029 |  |  |  |  |  |  |  | 09-040 |  |  |  | 6 |  |  |  |  |  |  |  |  |
| 13422046 |  | Vend Fab Quads (EXIST ARC Q-POLES) LABOR Final FY09 |  | 42d | 2009-08-03 | 2009-09-30 | 13422045 | 576d | 0d | MECH ENG [22.25 h]; MECH DES [17.8 h] | 2,200.12 | BEVINS M | 1 | 1 | MIKE B | 08-029 |  | APP | 08-016 |  |  | 3422 | 09-012 | 09-040 | 10-065 | 12-035F | 10-001B |  |  |  |  |  |  |  |  |  |
| 13422047 |  | Vend Fab Quads (EXIST ARC Q-POLES) Recieve Materials |  | 45d | 2009-08-03 | 2009-10-05 | 9-090M FS+206d | 839d | 263d | PROCUREMENT<$50K 60 NO ESCALATION; PROCUREMENT>$50K 69 NO ESCALATION | 84,150 | BEVINS M | 1 | 1 | MIKE B | 08-029 |  | APP | 08-016 |  |  | 3422 | 09-012 | 09-040 | 10-065 | 12-035F | 10-001A |  |  |  |  |  |  |  |  |  |
| 13422047A |  | Vend Fab Quads (EXIST ARC Q-POLES) Lamination Stampings |  | 1d | 2009-08-03 | 2009-08-03 | 9-090M FS+206d | 883d | 307d | PROCUREMENT>$50K 69 | 19,125 | BEVINS M | 1 | 1 | MIKE B | 08-029 |  | APP | 08-016 |  |  | 3422 | 09-012 | 09-040 | 10-065 | 12-035F |  |  |  |  |  |  |  |  |  |  |
| 13422047B |  | Vend Fab Quads (EXIST ARC Q-POLES) First Article QR |  | 62d | 2009-08-03 | 2009-10-28 | 9-090M FS+206d | 822d | 246d | PROCUREMENT>$50K 69 NO ESCALATION | 19,900 | BEVINS M | 1 | 1 | MIKE B | 08-029 |  | APP | 08-016 |  |  | 3422 | 09-012 | 09-040 | 10-065 | 12-035F | 10-001A |  |  |  |  |  |  |  |  |  |
| 13422047C |  | Vend Fab Quads (EXIST ARC Q-POLES) Deliver 5 QR Magnets |  | 120d | 2009-08-03 | 2010-01-29 | 9-090M FS+206d | 764d | 188d | PROCUREMENT>$50K 69 NO ESCALATION | 38,500 | BEVINS M | 1 | 1 | MIKE B | 08-029 |  | APP | 08-016 |  |  | 3422 | 09-012 | 09-040 | 10-065 | 12-035F | 10-001A |  |  |  |  |  |  |  |  |  |
| 13422047D |  | Vend Fab Quads (EXIST ARC Q-POLES) Deliver 5 QR Magnets |  | 139d | 2009-08-03 | 2010-02-26 | 9-090M FS+206d | 745d | 169d | PROCUREMENT>$50K 69 NO ESCALATION | 38,500 | BEVINS M | 1 | 1 | MIKE B | 08-029 |  | APP | 08-016 |  |  | 3422 | 09-012 | 09-040 | 10-065 | 12-035F | 10-001A |  |  |  |  |  |  |  |  |  |
| 13422047F |  | Vend Fab Quads (EXIST ARC Q-POLES) Deliver 5 QR Magnets |  | 160d | 2009-08-03 | 2010-03-29 | 9-090M FS+206d | 724d | 148d | PROCUREMENT>$50K 69 NO ESCALATION | 38,500 | BEVINS M | 1 | 1 | MIKE B | 08-029 |  | APP | 08-016 |  |  | 3422 | 09-012 | 09-040 | 10-065 | 12-035F | 10-001A |  |  |  |  |  |  |  |  |  |
| 13422047G |  | Vend Fab Quads (EXIST ARC Q-POLES) Deliver 5 QR Magnets |  | 184d | 2009-08-03 | 2010-04-30 | 9-090M FS+206d | 700d | 124d | PROCUREMENT>$50K 69 NO ESCALATION | 38,500 | BEVINS M | 1 | 1 | MIKE B | 08-029 |  | APP | 08-016 |  |  | 3422 | 09-012 | 09-040 | 10-065 | 12-035F | 10-001A |  |  |  |  |  |  |  |  |  |
| 13422047H |  | Vend Fab Quads (EXIST ARC Q-POLES) Deliver 5 QR Magnets |  | 204d | 2009-08-03 | 2010-05-28 | 9-090M FS+206d | 680d | 104d | PROCUREMENT>$50K 69 NO ESCALATION | 38,500 | BEVINS M | 1 | 1 | MIKE B | 08-029 |  | APP | 08-016 |  |  | 3422 | 09-012 | 09-040 | 10-065 | 12-035F | 10-001A |  |  |  |  |  |  |  |  |  |
| 13422047J |  | Vend Fab Quads (EXIST ARC Q-POLES) Deliver 5 QR Magnets |  | 221d | 2009-08-03 | 2010-06-23 | 9-090M FS+206d | 663d | 87d | PROCUREMENT>$50K 69 NO ESCALATION | 38,500 | BEVINS M | 1 | 1 | MIKE B | 08-029 |  | APP | 08-016 |  |  | 3422 | 09-012 | 09-040 | 10-065 | 12-035F | 10-001A |  |  |  |  |  |  |  |  |  |
| 13422047K |  | Vend Fab Quads (EXIST ARC Q-POLES) Deliver 4 QR Magnets |  | 243d | 2009-08-03 | 2010-07-26 | 9-090M FS+206d | 641d | 65d | PROCUREMENT>$50K 69 NO ESCALATION | 30,800 | BEVINS M | 1 | 1 | MIKE B | 08-029 |  | APP | 08-016 |  |  | 3422 | 09-012 | 09-040 | 10-065 | 12-035F | 10-001A |  |  |  |  |  |  |  |  |  |
| 13422047L |  | Vend Fab Quads (EXIST ARC Q-POLES) Deliver 2 QR Magnets |  | 308d | 2009-08-03 | 2010-10-26 | 9-090M FS+206d | 576d | 0d | PROCUREMENT<$50K 60 NO ESCALATION; PROCUREMENT>$50K 69 NO ESCALATION | 20,600 | BEVINS M | 1 | 1 | MIKE B | 08-029 |  | APP | 08-016 |  |  | 3422 | 09-012 | 09-040 | 10-065 | 12-035F | 10-001A |  |  |  |  |  |  |  |  |  |
| 13422046b |  | Vend Fab Quads (EXIST ARC Q-POLES) LABOR Final FY10 |  | 248d | 2009-10-01 | 2010-09-30 | 13422046 | 576d | 0d | MECH ENG [131.37 h]; MECH DES [105.07 h] | 13,404.08 | BEVINS M | 1 | 1 | MIKE B |  |  | APP |  |  |  | 3422 |  |  | 10-065 | 12-035F | 10-001B |  | 11-001 |  |  |  |  |  |  |  |
| 13432004b |  | Procurement Prep for Linac Correctors FY10 |  | 53d | 2009-10-01 | 2009-12-16 | 13432004 | 302d | 0d | MECH ENG [18.28 h]; MECH DES [18.28 h] | 2,030.73 | BEVINS M | 1 | 1 | MIKE B |  |  |  |  |  |  |  |  |  |  |  | 10-001B |  |  |  |  |  |  |  |  |  |
| 13422100 |  | Prcrmnt Prep for QY Quads FY10a |  | 64d | 2010-04-01 | 2010-06-30 | 9-100M FS+120d | 528d | 0d | MECH DES [211.25 h]; MECH ENG [273.4 h] | 27,560.34 | BEVINS M | 1 | 1 | MIKE B |  |  |  |  |  |  |  |  |  | 10-065 | 12-035F |  |  |  | 10-030 | 11-057 | 12-018F | 12-029F |  |  |  |
| 13422055 |  | Mag Measurment of New Quads (EXIST ARC Q-POLES) FY10 |  | 104d | 2010-05-05 | 2010-09-30 | 13422050M FS-122d | 576d | 0d | MECH TECH [108.16 h]; MECH ENG [64.48 h] | 8,760.61 | BEVINS M | 1 | 1 | MIKE B | 08-029 |  |  |  |  |  |  |  | 09-040 | 10-065 | 12-035F |  |  | 11-001 |  |  |  |  |  |  |  |
| 13422102 |  | Prcrmnt Prep for QY Quads FY10b |  | 64d | 2010-07-01 | 2010-09-30 | 13422100 | 528d | 0d | MECH ENG [497.72 h]; MECH DES [384.62 h] | 50,175.07 | BEVINS M | 1 | 1 | MIKE B |  |  |  |  |  |  |  |  |  | 10-065 | 12-035F |  |  | 11-001 | 10-030 | 11-057 | 12-018F | 12-029F |  |  |  |
| 13422046ba |  | Vend Fab Quads (EXIST ARC Q-POLES) LABOR Final FY11 |  | 18d | 2010-10-01 | 2010-10-26 | 13422046b | 576d | 0d | MECH DES [7.63 h]; MECH ENG [9.53 h] | 1,003.73 | BEVINS M | 1 | 1 | MIKE B |  |  | APP |  |  |  | 3422 |  |  | 10-065 | 12-035F | 10-001B |  | 11-001 |  |  |  |  |  |  |  |
| 13422055a |  | Mag Measurment of New Quads (EXIST ARC Q-POLES) FY11 |  | 96d | 2010-10-01 | 2011-02-25 | 13422055 | 576d | 297d | MECH ENG [59.52 h]; MECH TECH [99.84 h] | 8,344.49 | BEVINS M | 1 | 1 | MIKE B | 08-029 |  |  |  |  |  |  |  | 09-040 | 10-065 | 12-035F |  |  | 11-001 |  |  |  |  |  |  |  |
| 13422102a |  | Prcrmnt Prep for QY Quads FY11 |  | 14d | 2010-10-01 | 2010-10-20 | 13422102 | 528d | 0d | MECH DES [84.13 h]; MECH ENG [108.88 h] | 11,325.59 | BEVINS M | 1 | 1 | MIKE B |  |  |  |  |  |  |  |  |  | 10-065 | 12-035F |  |  | 11-001 | 10-030 | 11-057 | 12-018F | 12-029F |  |  |  |
| 13422105M |  | Award Contract for QY Quadrupoles | milestone | 0d | 2010-10-21 | 2010-10-21 | 13422102a | 528d | 0d |  |  | BEVINS M | 1 | 1 | MIKE B |  |  |  |  |  |  |  |  |  | 10-065 | 12-035F |  | 6 |  | 10-030 | 11-057 | 12-018F | 12-029F |  |  |  |
| 13422110 |  | Vend Fab QY Quads Labor Support FY11 |  | 170d | 2010-10-21 | 2011-06-30 | 13422105M | 528d | 0d | MECH DES [80 h]; MECH ENG [320 h] | 25,478.4 | BEVINS M | 1 | 1 | MIKE B |  |  | APP |  |  |  | 3422 |  |  | 10-065 | 12-035F |  |  |  | 10-030 | 11-057 | 12-018F | 12-029F |  |  |  |
| 13422115 |  | Vend Fab QY Quads 1st Article |  | 106d | 2010-10-21 | 2011-03-31 | 13422105M | 528d | 0d | PROCUREMENT<$50K 60 | 41,276 | BEVINS M | 1 | 1 | MIKE B |  |  | APP |  |  |  | 3422 |  |  | 10-065 | 12-035F |  |  |  | 10-030 | 11-057 | 12-018F | 12-029F |  |  |  |
| 13422050M |  | Delivery Complete for Quadrupoles(EXIST ARC Q-POLES) | milestone | 0d | 2010-10-26 | 2010-10-26 | 13422047K, 13422047C, 13422047B, 13422047, 13422047D, 13422047F, 13422047A, 13422047J, 13422047L, 13422047H, 13422047G, 13422046ba | 576d | 0d |  |  | BEVINS M | 1 | 1 | MIKE B | 08-029 |  |  |  |  |  |  |  | 09-040 | 10-065 | 12-035F |  | 6 |  |  |  |  |  |  |  |  |
| 13422122 |  | Receive and Inspect QY Quads |  | 127d | 2011-01-31 | 2011-07-29 | 13422115 FS-43d | 528d | 212d | MECH ENG [74.34 h]; MECH DES [24.78 h]; COMP SCIENT [24.78 h]; MECH TECH [74.34 h] | 10,985.71 | BEVINS M | 1 | 1 | MIKE B |  |  | APP |  |  |  | 3422 |  |  | 10-065 | 12-035F |  |  |  | 10-030 | 11-057 | 12-018F | 12-029F |  |  |  |
| 13422123 |  | Magnetic Measurement QY Quads |  | 106d | 2011-03-02 | 2011-07-29 | 13422122 FS-500d, 9-110M FS+98d, 13422125M FS-500d | 528d |  | MECH TECH [115.22 h]; MECH ENG [23.04 h] | 6,528.1 | BEVINS M | 1 | 1 | MIKE B |  |  | APP |  |  |  | 3422 |  |  | 10-065 | 12-035F |  |  |  | 10-030 | 11-057 | 12-018F | 12-029F |  |  |  |
| 13422112 |  | Vend Fab QY Quads Labor Support FY12 |  | 20d | 2011-07-01 | 2011-07-29 | 13422110 | 528d | 212d | MECH DES [20.51 h]; MECH ENG [82.05 h] | 6,532.71 | BEVINS M | 1 | 1 | MIKE B |  |  | APP |  |  |  | 3422 |  |  | 10-065 | 12-035F |  |  |  | 10-030 | 11-057 | 12-018F | 12-029F |  |  |  |
| 13422123a |  | Magnetic Measurement QR Quads FY11 |  | 16d | 2011-09-09 | 2011-09-30 | 13422122 FS-184d, 13422125M FS-184d | 316d | 0d | MECH TECH [7.37 h]; MECH ENG [1.47 h] | 417.32 | BEVINS M | 1 | 1 | MIKE B |  |  | APP |  |  |  | 3422 |  |  | 10-065 | 12-035F |  |  |  | 10-030 | 11-057 | 12-018F | 12-029F | 12-001 |  |  |
| 13422065 |  | Measure 69 S/R Quads at Higher Current (EXIST ARC Q-POLES) |  | 50d | 2011-10-03 | 2011-12-13 | 9-120M | 197d |  |  |  | BEVINS M | 1 | 1 | MIKE B | 08-029 |  |  |  |  |  |  |  |  | 10-065 |  |  |  |  |  |  |  |  |  |  |  |
| 13422123b |  | Magnetic Measurement QR Quads FY12 |  | 168d | 2011-10-03 | 2012-06-08 | 13422123a | 316d |  | MECH TECH [77.41 h]; MECH ENG [15.49 h] | 4,526.26 | BEVINS M | 1 | 1 | MIKE B |  |  | APP |  |  |  | 3422 |  |  | 10-065 | 12-035F |  |  |  | 10-030 | 11-057 | 12-018F | 12-029F | 12-001 |  |  |
| 13422117 |  | Vend Fab QR Quads Labor Support |  | 133d | 2011-11-14 | 2012-05-31 | 9-120M FS+30d | 321d | 5d | MECH DES [59.49 h]; MECH ENG [237.95 h] | 19,550.68 | BEVINS M | 1 | 1 | MIKE B |  |  | APP |  |  |  | 3422 |  |  | 10-065 | 12-035F |  |  |  | 10-030 | 11-057 | 12-018F | 12-029F |  |  |  |
| 13422120 |  | Vend Fab Additional QR Quads |  | 133d | 2011-11-14 | 2012-05-31 | 9-120M FS+30d, 13422115 FS-106d | 316d | 0d | PROCUREMENT<$50K 60; PROCUREMENT>$50K 69 | 62,243.18 | BEVINS M | 1 | 1 | MIKE B |  |  | APP |  |  |  | 3422 |  |  | 10-065 | 12-035F |  |  |  | 10-030 | 11-057 | 12-018F | 12-029F |  |  |  |
| 13422060 |  | Add Klixons to 20 Amp Quads (EXIST ARC Q-POLES) |  | 60d | 2012-05-07 | 2012-07-31 | 2-02M FS-5d, 13422055a | 279d |  | PROCUREMENT<$50K 60; MECH TECH [132 h]; PROCUREMENT>$50K 69 | 32,386.53 | BEVINS M | 1 | 1 | MIKE B | 08-029 |  | APP |  | 08-044 |  |  |  |  | 10-065 | 12-035 |  |  |  |  |  |  |  |  |  |  |
| 13422122a |  | Receive and Inspect QR Quads |  | 5d | 2012-06-01 | 2012-06-08 | 13422120 | 316d | 0d | MECH TECH [45.66 h]; MECH ENG [45.66 h]; MECH DES [15.22 h]; COMP SCIENT [15.22 h] | 6,962.7 | BEVINS M | 1 | 1 | MIKE B |  |  | APP |  |  |  | 3422 |  |  | 10-065 | 12-035F |  |  |  | 10-030 | 11-057 | 12-018F | 12-029F |  |  |  |
| 13422125M |  | Delivery Complete for QR Quadrupoles | milestone | 0d | 2012-06-08 | 2012-06-08 | 13422117, 13422112, 13422120, 13422122a, 13422115, 13422122 | 316d | 0d |  |  | BEVINS M | 1 | 1 | MIKE B |  |  |  |  |  |  |  |  |  | 10-065 | 12-035F |  | 6 |  | 10-030 | 11-057 | 12-018F | 12-029F |  |  |  |
| 13422130 |  | Re-Baseline Actuals Adjustment |  | 1d | 2013-08-30 | 2013-08-30 | 9-130M FS+227d | 20d |  | PROCUREMENT>$50K 69 NO ESCALATION | -78,852.33 | BEVINS M | 1 | 1 | MIKE B |  |  |  |  |  |  |  |  |  |  |  |  |  |  |  |  |  |  |  | 13-014 | ADJ |

Notes:
- 13422122: Steps: Mechanical Inspection QY 1st Article; Magnetic Measurement QY 1st Article; Mechanical Inspection QY2; Magnetic Measurement QY2; Mechanical Inspection QY3; Magnetic Measurement QY3; Mechanical Inspection QY4; Magnetic Measurement QY4; Mechanical Inspection QY5; Magnetic Measurement QY5
- 13422123: Steps: Mechanical Inspection QY 1st Article; Magnetic Measurement QY 1st Article; Mechanical Inspection QY2; Magnetic Measurement QY2; Mechanical Inspection QY3; Magnetic Measurement QY3; Mechanical Inspection QY4; Magnetic Measurement QY4; Mechanical Inspection QY5; Magnetic Measurement QY5
- 13422123a: Steps: Mechanical Inspection QY 1st Article; Magnetic Measurement QY 1st Article; Mechanical Inspection QY2; Magnetic Measurement QY2; Mechanical Inspection QY3; Magnetic Measurement QY3; Mechanical Inspection QY4; Magnetic Measurement QY4; Mechanical Inspection QY5; Magnetic Measurement QY5
- 13422123b: Steps: Mechanical Inspection QY 1st Article; Magnetic Measurement QY 1st Article; Mechanical Inspection QY2; Magnetic Measurement QY2; Mechanical Inspection QY3; Magnetic Measurement QY3; Mechanical Inspection QY4; Magnetic Measurement QY4; Mechanical Inspection QY5; Magnetic Measurement QY5
- 13422122a: Steps: Mechanical Inspection QY 1st Article; Magnetic Measurement QY 1st Article; Mechanical Inspection QY2; Magnetic Measurement QY2; Mechanical Inspection QY3; Magnetic Measurement QY3; Mechanical Inspection QY4; Magnetic Measurement QY4; Mechanical Inspection QY5; Magnetic Measurement QY5

| ID | WBS | Activity | Type | Duration | Start | Finish | Predecessors | Total float | Free float | Calendar | Resources | Cost | RESP - Responsibility | STRT%COMP for CM EVM | FNSH%COMP for CM EVM | CAM RESPONSIBLE | CR 09-034 | CR 11-057 | CR 08-016 | CR 09-012 | CR 10-030 | CR 13-014 | ReBaseline Actuals Adjustment | Proj SYS CODE | DOWN PERIOD | 12GEV INSTALLATION SCOPE | CR 10-065 | CR 11-001 | 12GEV PROJ ACT ID | LOCATION NAME | CR 10-028 | CR 12-035 | CR 07-024 | CR 11-052 | CR 12-053 | CR 08-044 | CR 12-028 | CR 08-029 | CR 13-003 | CR 12-018 | CR 12-029 | Original Activity ID Rebaseline | EVMS Reporting Codes | BOE Labor | CR 13-015 | Post Rebaseline |
| --- | --- | --- | --- | --- | --- | --- | --- | --- | --- | --- | --- | --- | --- | --- | --- | --- | --- | --- | --- | --- | --- | --- | --- | --- | --- | --- | --- | --- | --- | --- | --- | --- | --- | --- | --- | --- | --- | --- | --- | --- | --- | --- | --- | --- | --- | --- |
|  | 3 | **1.3.4.2.3 CORRECTORS** |  |  |  |  |  |  |  |  |  |  |  |  |  |  |  |  |  |  |  |  |  |  |  |  |  |  |  |  |  |  |  |  |  |  |  |  |  |  |  |  |  |  |  |  |
|  | 4 | **1.3.4.2.4 STANDS** |  |  | 2009-01-05 | 2013-08-30 |  |  |  |  |  |  |  |  |  |  |  |  |  |  |  |  |  |  |  |  |  |  |  |  |  |  |  |  |  |  |  |  |  |  |  |  |  |  |  |  |
| 13425020 |  | Proc Girder Matrl (EXIST ARC Girders) |  | 102d | 2009-01-05 | 2009-05-29 | 121425010, 9-090M FS+60d | 592d | 439d |  | MECH ENG [27.2 h]; MECH DES [27.2 h] | 2,928.08 | BEVINS M | 1 | 1 | MIKE B | 09-034 | 11-057 |  |  |  |  |  |  |  |  |  |  |  |  |  |  |  |  |  |  |  |  |  |  |  |  |  |  |  |  |
| 13425025 |  | Proc Prep of Girders/Stands for QY Quads (EXIST ARC Girders) |  | 79d | 2011-03-11 | 2011-06-30 | 9-110M FS+105d, 13425020 | 153d | 144d |  | MECH DES [240 h]; MECH ENG [208 h] | 25,336.8 | BEVINS M | 1 | 1 | MIKE B | 09-034 | 11-057 | 08-016 | 09-012 | 10-030 |  |  |  |  |  |  |  |  |  |  |  |  |  |  |  |  |  |  |  |  |  |  |  |  |  |
| 13425030 |  | Vend Fab Girders/Stands for QY Quads (EXIST ARC Girders) |  | 61d | 2012-02-03 | 2012-04-30 | 13425020, 13425025, 9-120M FS+80d | 9d |  |  | PROCUREMENT<$50K 60 | 28,790.02 | BEVINS M | 1 | 1 | MIKE B | 09-034 | 11-057 | 08-016 | 09-012 | 10-030 |  |  |  |  |  |  |  |  |  |  |  |  |  |  |  |  |  |  |  |  |  |  |  |  |  |
| 13425035 |  | Re-Baseline Actuals Adjustment |  | 1d | 2013-08-30 | 2013-08-30 | 9-130M FS+227d | 20d |  |  | PROCUREMENT>$50K 69 NO ESCALATION | -36,112.05 | BEVINS M | 1 | 1 | MIKE B |  |  |  |  |  | 13-014 | ADJ |  |  |  |  |  |  |  |  |  |  |  |  |  |  |  |  |  |  |  |  |  |  |  |
|  | 5 | **1.3.4.2.5 GIRDERS** |  |  |  |  |  |  |  |  |  |  |  |  |  |  |  |  |  |  |  |  |  |  |  |  |  |  |  |  |  |  |  |  |  |  |  |  |  |  |  |  |  |  |  |  |
|  | 6 | **1.3.4.2.6 VACUUM** |  |  | 2013-08-30 | 2013-08-30 |  |  |  |  |  |  |  |  |  |  |  |  |  |  |  |  |  |  |  |  |  |  |  |  |  |  |  |  |  |  |  |  |  |  |  |  |  |  |  |  |
| 13426000 |  | Re-Baseline Actuals Adjustment |  | 1d | 2013-08-30 | 2013-08-30 | 9-130M FS+227d | 20d |  |  | PROCUREMENT>$50K 69 NO ESCALATION | 4,286.31 | BEVINS M | 1 | 1 | MIKE B |  |  |  |  |  | 13-014 | ADJ |  |  |  |  |  |  |  |  |  |  |  |  |  |  |  |  |  |  |  |  |  |  |  |
|  | 7 | **1.3.4.2.7 INSTALLATION** |  |  | 2010-07-02 | 2013-11-18 |  |  |  |  |  |  |  |  |  |  |  |  |  |  |  |  |  |  |  |  |  |  |  |  |  |  |  |  |  |  |  |  |  |  |  |  |  |  |  |  |
| 13427180 |  | Accelerator Down Planning FY10 |  | 63d | 2010-07-02 | 2010-09-30 | 9-100M FS+185d | 3d | 0d |  | MECH ENG [288 h]; MECH TECH [144 h] | 24,975.36 | BEVINS M | 1 | 1 | MIKE B |  |  |  |  |  |  |  | BM TR 12GE | 6MON | W/A DIPOLES | 10-065 | 11-001 |  |  |  |  |  |  |  |  |  |  |  |  |  |  |  |  |  |  |
| 13427180a |  | Accelerator Down Planning FY11 |  | 147d | 2010-10-01 | 2011-05-09 | 13427180 | 3d |  |  | MECH TECH [336 h]; MECH ENG [672 h] | 60,133.92 | BEVINS M | 1 | 1 | MIKE B |  |  |  |  |  |  |  | BM TR 12GE | 6MON | W/A DIPOLES | 10-065 | 11-001 |  |  |  |  |  |  |  |  |  |  |  |  |  |  |  |  |  |  |
| 13427055 |  | Procure new material handling equipment |  | 107d | 2010-11-05 | 2011-04-18 | 9-110M FS+25d | 18d |  |  | PROCUREMENT<$50K 60; MECH TECH [80 h] | 137,592.6 | BEVINS M | 1 | 1 | MIKE B |  |  |  |  |  |  |  |  |  |  | 10-065 |  |  |  |  |  |  |  |  |  |  |  |  |  |  |  |  |  |  |  |
| 13427060 |  | Procure Temporary Space for expanded technician work force |  | 127d | 2011-03-04 | 2011-08-31 | 9-110M FS+100d | 51d |  |  | PROCUREMENT<$50K 60; PROCUREMENT>$50K 69 | 77,392.5 | BEVINS M | 1 | 1 | MIKE B |  |  |  |  |  |  |  |  |  |  | 10-065 |  |  |  |  |  |  |  |  |  |  |  |  |  |  |  |  |  |  |  |
| 13427063LOE |  | Tech Training |  | 40d | 2011-03-04 | 2011-04-28 | 9-110M FS+100d | 10d |  |  | MECH TECH [5280 h]; MECH ENG [160 h] | 238,281.6 | BEVINS M | 1 | 1 | MIKE B |  |  |  |  |  |  |  |  |  |  | 10-065 |  |  |  |  |  |  |  |  |  |  |  |  |  |  |  |  |  |  |  |
| 13427062LOE |  | Engineering Support 6 Month Down |  | 80d | 2011-05-13 | 2011-09-06 | 4A-01M | 48d |  |  | MECH ENG [1440 h] | 97,848 | BEVINS M | 1 | 1 | MIKE B |  |  |  |  |  |  |  |  |  |  | 10-065 |  |  |  |  |  |  |  |  |  |  |  |  |  |  |  |  |  |  |  |
| 13427065 |  | AS-FOUND SURVEY (B/L UNDER VACUUM) SOUTH SIDE WEST ARC |  | 8d | 2011-05-20 | 2011-06-01 | 4A-01M FS+5d | 46d | 0d |  | MECH TECH [220.8 h] | 9,509.86 | BEVINS M | 1 | 1 | MIKE B |  |  |  |  |  |  |  | BM TR 12GE | 6MON | W/A DIPOLES | 10-065 |  |  |  |  |  |  |  |  |  |  |  |  |  |  |  |  |  |  |  |
| 13427070 |  | BLEED UP VACUUM SOUTH SIDE OF W/ARC |  | 1d | 2011-06-02 | 2011-06-02 | 13427065 | 46d | 0d |  | MECH TECH [20 h] | 861.4 | BEVINS M | 1 | 1 | MIKE B |  |  |  |  |  |  |  | BM TR 12GE | 6MON | W/A DIPOLES | 10-065 |  | 13427030 | W Arc Quad 2 Stack 8 |  |  |  |  |  |  |  |  |  |  |  |  |  |  |  |  |
| 13427075 |  | AS-FOUND SURVEY (B/L UNDER VACUUM) NORTH SIDE WEST ARC |  | 8d | 2011-06-02 | 2011-06-13 | 13427065 | 57d | 0d |  | MECH TECH [220.8 h] | 9,509.86 | BEVINS M | 1 | 1 | MIKE B |  |  |  |  |  |  |  | BM TR 12GE | 6MON | W/A DIPOLES | 10-065 |  |  |  |  |  |  |  |  |  |  |  |  |  |  |  |  |  |  |  |
| 13427120 |  | REMOVE MAGNETS - QUAD 1 |  | 5d | 2011-06-03 | 2011-06-09 | 3A-34M, 13427070 | 46d | 0d |  | ELEC TECH [36.8 h]; MECH TECH [404.8 h] | 19,008.68 | BEVINS M | 1 | 1 | MIKE B |  |  |  |  |  |  |  |  | 6MON |  | 10-065 |  |  |  |  |  |  |  |  |  |  |  |  |  |  |  |  |  |  |  |
| 13427125 |  | REFURB, UPGRADE AND TEST MAGNETS - QUAD 1 |  | 11d | 2011-06-08 | 2011-06-22 | 13427120 FS-2d | 46d | 0d |  | MSHOP; MECH TECH [1545.6 h] | 80,437.73 | BEVINS M | 1 | 1 | MIKE B |  |  |  |  |  |  |  | BM TR 12GE | 6MON | W/A DIPOLES | 10-065 |  |  |  |  |  |  |  |  |  |  |  |  |  |  |  |  |  |  |  |
| 13427135 |  | REMOVE MAGNETS - QUAD 2 |  | 4d | 2011-06-08 | 2011-06-13 | 13427120 FS-2d | 52d | 6d |  | MECH TECH [404.8 h]; ELEC TECH [36.8 h] | 19,008.68 | BEVINS M | 1 | 1 | MIKE B |  |  |  |  |  |  |  |  | 6MON |  | 10-065 |  |  |  |  |  |  |  |  |  |  |  |  |  |  |  |  |  |  |  |
| 13427080 |  | BLEED UP VACUUM NORTH SIDE OF W/ARC |  | 1d | 2011-06-14 | 2011-06-14 | 13427075 | 57d | 0d |  | MECH TECH [20 h] | 861.4 | BEVINS M | 1 | 1 | MIKE B |  |  |  |  |  |  |  | BM TR 12GE | 6MON | W/A DIPOLES | 10-065 |  | 13427030 | W Arc Quad 2 Stack 8 |  |  |  |  |  |  |  |  |  |  |  |  |  |  |  |  |
| 13427130 |  | INSTALL MAGNETS AND ARC 10 - QUAD 1 |  | 19d | 2011-06-15 | 2011-07-12 | 13427125 FS-6d | 72d | 6d |  | ELEC TECH [73.6 h]; MECH TECH [818.8 h] | 38,413.59 | BEVINS M | 1 | 1 | MIKE B |  |  |  |  |  |  |  | BM TR 12GE | 6MON | W/A DIPOLES | 10-065 |  |  |  |  |  |  |  |  |  |  |  |  |  |  |  |  |  |  |  |
| 13427150 |  | REMOVE MAGNETS - QUAD 3 |  | 4d | 2011-06-15 | 2011-06-20 | 13427080 | 57d | 0d |  | MECH TECH [404.8 h]; ELEC TECH [36.8 h] | 19,008.68 | BEVINS M | 1 | 1 | MIKE B |  |  |  |  |  |  |  |  | 6MON |  | 10-065 |  |  |  |  |  |  |  |  |  |  |  |  |  |  |  |  |  |  |  |
| 13427165 |  | REMOVE MAGNETS - QUAD 4 |  | 6d | 2011-06-20 | 2011-06-27 | 13427150 FS-1d | 61d | 15d |  | ELEC TECH [36.8 h]; MECH TECH [404.8 h] | 19,008.68 | BEVINS M | 1 | 1 | MIKE B |  |  |  |  |  |  |  |  | 6MON |  | 10-065 |  |  |  |  |  |  |  |  |  |  |  |  |  |  |  |  |  |  |  |
| 13427140 |  | REFURB, UPGRADE AND TEST MAGNETS - QUAD 2 |  | 10d | 2011-06-22 | 2011-07-06 | 13427135, 13427125 FS-1d | 46d | 0d |  | MECH TECH [1545.6 h]; MSHOP | 80,437.73 | BEVINS M | 1 | 1 | MIKE B |  |  |  |  |  |  |  | BM TR 12GE | 6MON | W/A DIPOLES | 10-065 |  |  |  |  |  |  |  |  |  |  |  |  |  |  |  |  |  |  |  |
| 13427145 |  | INSTALL MAGNETS AND ARC 10 - QUAD 2 |  | 16d | 2011-06-28 | 2011-07-20 | 13427140 FS-6d | 66d | 0d |  | ELEC TECH [73.6 h]; MECH TECH [920 h] | 42,772.27 | BEVINS M | 1 | 1 | MIKE B |  |  |  |  |  |  |  | BM TR 12GE | 6MON | W/A DIPOLES | 10-065 |  |  |  |  |  |  |  |  |  |  |  |  |  |  |  |  |  |  |  |
| 13427155 |  | REFURB, UPGRADE AND TEST MAGNETS - QUAD 3 |  | 10d | 2011-07-07 | 2011-07-20 | 13427150, 13427140 | 46d | 0d |  | MECH TECH [1545.6 h]; MSHOP | 80,437.73 | BEVINS M | 1 | 1 | MIKE B |  |  |  |  |  |  |  | BM TR 12GE | 6MON | W/A DIPOLES | 10-065 |  |  |  |  |  |  |  |  |  |  |  |  |  |  |  |  |  |  |  |
| 13427160 |  | INSTALL MAGNETS AND ARC 10 - QUAD 3 |  | 26d | 2011-07-12 | 2011-08-16 | 13427155 FS-7d | 50d | 4d |  | ELEC TECH [73.6 h]; MECH TECH [920 h] | 42,772.27 | BEVINS M | 1 | 1 | MIKE B |  |  |  |  |  |  |  | BM TR 12GE | 6MON | W/A DIPOLES | 10-065 |  |  |  |  |  |  |  |  |  |  |  |  |  |  |  |  |  |  |  |
| 13427170 |  | REFURB, UPGRADE AND TEST MAGNETS - QUAD 4 |  | 10d | 2011-07-20 | 2011-08-02 | 13427165, 13427155 FS-1d | 46d | 0d |  | MSHOP; MECH TECH [1545.6 h] | 80,437.73 | BEVINS M | 1 | 1 | MIKE B |  |  |  |  |  |  |  | BM TR 12GE | 6MON | W/A DIPOLES | 10-065 |  |  |  |  |  |  |  |  |  |  |  |  |  |  |  |  |  |  |  |
| 13427085 |  | PUMP OUT SOUTH SIDE WEST ARC |  | 3d | 2011-07-21 | 2011-07-25 | 13427130, 13427145 | 66d | 0d |  | MECH TECH [73.6 h] | 3,169.95 | BEVINS M | 1 | 1 | MIKE B |  |  |  |  |  |  |  | BM TR 12GE | 6MON | W/A DIPOLES | 10-065 |  |  |  |  |  |  |  |  |  |  |  |  |  |  |  |  |  |  |  |
| 13427090 |  | QA CHECKS - SOUTH SIDE WEST ARC |  | 4d | 2011-07-25 | 2011-07-28 | 13427085 FS-1d | 66d | 0d |  | MECH TECH [128.8 h]; ELEC TECH [64.4 h] | 8,301.81 | BEVINS M | 1 | 1 | MIKE B |  |  |  |  |  |  |  | BM TR 12GE | 6MON | W/A DIPOLES | 10-065 |  |  |  |  |  |  |  |  |  |  |  |  |  |  |  |  |  |  |  |
| 13427175 |  | INSTALL MAGNETS AND ARC 10 - QUAD 4 |  | 21d | 2011-07-25 | 2011-08-22 | 13427170 FS-7d | 46d | 0d |  | MECH TECH [818.8 h]; ELEC TECH [73.6 h] | 38,413.59 | BEVINS M | 1 | 1 | MIKE B |  |  |  |  |  |  |  | BM TR 12GE | 6MON | W/A DIPOLES | 10-065 |  |  |  |  |  |  |  |  |  |  |  |  |  |  |  |  |  |  |  |
| 13427095 |  | 2B FINAL STACK ALIGNMENT (B/L UNDER VACUUM) - SOUTH SIDE WEST ARC |  | 9d | 2011-07-29 | 2011-08-10 | 13427090 | 66d | 20d |  | MECH TECH [220.8 h] | 9,509.86 | BEVINS M | 1 | 1 | MIKE B |  |  |  |  |  |  |  | BM TR 12GE | 6MON | W/A DIPOLES | 10-065 |  |  |  |  |  |  |  |  |  |  |  |  |  |  |  |  |  |  |  |
| 13427100 |  | PUMP OUT NORTH SIDE WEST ARC |  | 3d | 2011-08-23 | 2011-08-25 | 13427175, 13427160 | 46d | 0d |  | MECH TECH [73.6 h] | 3,169.95 | BEVINS M | 1 | 1 | MIKE B |  |  |  |  |  |  |  | BM TR 12GE | 6MON | W/A DIPOLES | 10-065 |  |  |  |  |  |  |  |  |  |  |  |  |  |  |  |  |  |  |  |
| 13427105 |  | QA CHECKS - NORTH SIDE WEST ARC |  | 4d | 2011-08-25 | 2011-08-30 | 13427100 FS-1d | 46d | 0d |  | MECH TECH [128.8 h]; ELEC TECH [64.4 h] | 8,301.81 | BEVINS M | 1 | 1 | MIKE B |  |  |  |  |  |  |  | BM TR 12GE | 6MON | W/A DIPOLES | 10-065 |  |  |  |  |  |  |  |  |  |  |  |  |  |  |  |  |  |  |  |
| 13427110 |  | 2B FINAL STACK ALIGNMENT (B/L UNDER VACUUM) - NORTH SIDE WEST ARC |  | 7d | 2011-08-30 | 2011-09-08 | 13427105 FS-1d | 46d | 0d |  | MECH TECH [220.8 h] | 9,509.86 | BEVINS M | 1 | 1 | MIKE B |  |  |  |  |  |  |  | BM TR 12GE | 6MON | W/A DIPOLES | 10-065 |  |  |  |  |  |  |  |  |  |  |  |  |  |  |  |  |  |  |  |
| 13427115M |  | WEST ARC FINISHED | milestone | 0d | 2011-09-08 | 2011-09-08 | 13427110, 13427095 | 46d |  |  |  |  | BEVINS M | 1 | 1 | MIKE B |  |  |  |  |  |  |  | BM TR 12GE | 6MON | W/A DIPOLES | 10-065 |  |  |  |  |  |  |  |  |  |  |  |  |  |  |  |  |  |  |  |
| 13427015LOE |  | Installation Team Engineering Support FY12 (12 Month Down) |  | 106d | 2012-05-01 | 2012-09-28 | 2-02M FS-9d | 9d | 0d |  | MECH DES [2240 h] | 107,900.8 | BEVINS M | 1 | 1 | MIKE B |  |  |  |  |  |  |  |  |  |  | 10-065 |  |  |  | 10-028 | 12-035 |  |  |  |  |  |  |  |  |  |  |  |  |  |  |
| 13427022 |  | Rework of arcs 5, 7, and 9 Part B FY12 |  | 84d | 2012-06-01 | 2012-09-28 | 2-02M FS+13d | 225d | 0d |  | MECH TECH [1662.5 h] | 73,881.5 | BEVINS M | 1 | 1 | MIKE B |  |  | 08-016 | 09-012 |  |  |  |  |  |  | 10-065 |  |  |  |  |  | 07-024 | 11-052 | 12-053 |  |  |  |  |  |  |  |  |  |  |  |
| 13427023 |  | Rework of arcs 5, 7, and 9 Part C FY12 |  | 76d | 2012-06-14 | 2012-09-28 | 2-02M FS+21d | 174d | 0d |  | MECH TECH [1038.85 h] | 46,166.49 | BEVINS M | 1 | 1 | MIKE B |  |  | 08-016 | 09-012 |  |  |  |  |  |  | 10-065 |  |  |  |  |  | 07-024 | 11-052 | 12-053 |  |  |  |  |  |  |  |  |  |  |  |
| 13427024 |  | Rework of arcs 5, 7, and 9 Part D FY12 |  | 67d | 2012-06-27 | 2012-09-28 | 2-02M FS+30d | 153d | 0d |  | MECH TECH [843.05 h] | 37,465.14 | BEVINS M | 1 | 1 | MIKE B |  |  | 08-016 | 09-012 |  |  |  |  |  |  | 10-065 |  |  |  |  |  | 07-024 | 11-052 | 12-053 |  |  |  |  |  |  |  |  |  |  |  |
| 13427020 |  | Arcs 1 & 3 - Remove |  | 8d | 2012-08-02 | 2012-08-13 | 2-02M FS+56d, 3A-14M | 144d | 0d |  | MECH TECH [392 h]; MECH ENG [284 h] | 37,334.56 | BEVINS M | 1 | 1 | MIKE B |  |  | 08-016 | 09-012 |  |  |  |  |  |  | 10-065 |  |  |  |  | 12-035 | 07-024 | 11-052 |  |  |  |  |  |  |  |  |  |  |  |  |
| 13427025 |  | Arcs 1 & 3 - Refurb and measure FY12 |  | 38d | 2012-08-07 | 2012-09-28 | 2-02M FS+13d, 13427020 FS-5d | 144d | 0d |  | MECH TECH [694.86 h]; MECH ENG [290.04 h] | 51,217.18 | BEVINS M | 1 | 1 | MIKE B |  |  |  |  |  |  |  |  |  |  | 10-065 |  |  |  |  | 12-035 |  | 11-052 | 12-053 | 08-044 |  |  |  |  |  |  |  |  |  |  |
| 13427027 |  | Arcs 1 & 3 - Install FY12 |  | 38d | 2012-08-07 | 2012-09-28 | 13427025a FS-98d | 144d | 0d |  | MECH ENG [277.75 h]; MECH TECH [699.2 h] | 50,548.28 | BEVINS M | 1 | 1 | MIKE B |  |  | 08-016 | 09-012 |  |  |  |  |  |  | 10-065 |  |  |  |  | 12-035 | 07-024 | 11-052 | 12-053 |  |  |  |  |  |  |  |  |  |  |  |
| 13427021 |  | Rework of arcs 5, 7, and 9 Part A FY12 |  | 33d | 2012-08-14 | 2012-09-28 | 2-02M FS+5d, 3A-36M | 193d | 0d |  | MECH TECH [814.29 h] | 36,187.05 | BEVINS M | 1 | 1 | MIKE B |  |  | 08-016 | 09-012 |  |  |  |  |  |  | 10-065 |  |  |  |  | 12-035 | 07-024 | 11-052 | 12-053 |  |  |  |  |  |  |  |  |  |  |  |
| 13427016LOE |  | Installation Team Engineering Support FY13 (12 Month Down) *** Re-Baseline Split |  | 228d | 2012-10-01 | 2013-08-30 | 13427015LOE | 9d |  |  | MECH DES [1731.65 h] | 86,080.32 | BEVINS M | 1 | 1 | MIKE B |  |  |  |  |  | 13-014 |  |  |  |  | 10-065 |  |  |  |  | 12-035 |  |  |  |  |  |  |  |  |  |  |  |  |  |  |
| 13427021a |  | Rework of arcs 5, 7, and 9 Part A FY13 |  | 44d | 2012-10-01 | 2012-12-03 | 13427021 | 193d |  |  | MECH TECH [1085.71 h] | 49,790.66 | BEVINS M | 1 | 1 | MIKE B |  |  | 08-016 | 09-012 |  |  |  |  |  |  | 10-065 |  |  |  |  | 12-035 | 07-024 | 11-052 | 12-053 |  |  |  |  |  |  |  |  |  |  |  |
| 13427022a |  | Rework of arcs 5, 7, and 9 Part B FY13 |  | 12d | 2012-10-01 | 2012-10-16 | 13427022 | 225d |  |  | MECH TECH [237.5 h] | 10,891.75 | BEVINS M | 1 | 1 | MIKE B |  |  | 08-016 | 09-012 |  |  |  |  |  |  | 10-065 |  |  |  |  |  | 07-024 | 11-052 | 12-053 |  |  |  |  |  |  |  |  |  |  |  |
| 13427023a |  | Rework of arcs 5, 7, and 9 Part C FY13 |  | 63d | 2012-10-01 | 2013-01-07 | 13427023 | 174d |  |  | MECH TECH [861.15 h] | 39,492.34 | BEVINS M | 1 | 1 | MIKE B |  |  | 08-016 | 09-012 |  |  |  |  |  |  | 10-065 |  |  |  |  |  | 07-024 | 11-052 | 12-053 |  |  |  |  |  |  |  |  |  |  |  |
| 13427024a |  | Rework of arcs 5, 7, and 9 Part D FY13 |  | 84d | 2012-10-01 | 2013-02-06 | 13427024 | 153d |  |  | MECH TECH [1056.95 h] | 48,471.73 | BEVINS M | 1 | 1 | MIKE B |  |  | 08-016 | 09-012 |  |  |  |  |  |  | 10-065 |  |  |  |  |  | 07-024 | 11-052 | 12-053 |  |  |  |  |  |  |  |  |  |  |  |
| 13427025a |  | Arcs 1 & 3 - Refurb and measure FY13 |  | 60d | 2012-10-01 | 2013-01-02 | 13427025 | 144d | 0d |  | MECH TECH [1097.14 h]; MECH ENG [457.96 h] | 83,452.83 | BEVINS M | 1 | 1 | MIKE B |  |  |  |  |  |  |  |  |  |  | 10-065 |  |  |  |  | 12-035 |  | 11-052 | 12-053 | 08-044 |  |  |  |  |  |  |  |  |  |  |
| 13427027a |  | Arcs 1 & 3 - Install FY13 |  | 72d | 2012-10-01 | 2013-01-18 | 13427027 | 144d | 0d |  | MECH ENG [526.25 h]; MECH TECH [1324.8 h] | 98,834.78 | BEVINS M | 1 | 1 | MIKE B |  |  | 08-016 | 09-012 |  |  |  |  |  |  | 10-065 |  |  |  |  | 12-035 | 07-024 | 11-052 | 12-053 |  |  |  |  |  |  |  |  |  |  |  |
| 13427035 |  | Hall A - Remove |  | 7d | 2012-10-11 | 2012-10-19 | 9-130M FS+8d | 186d | 0d |  | MECH TECH [144 h]; MECH ENG [32 h] | 8,919.36 | BEVINS M | 1 | 1 | MIKE B |  |  |  |  |  |  |  |  |  |  | 10-065 |  |  |  |  | 12-035 |  | 11-052 |  |  | 12-028F |  |  |  |  |  |  |  |  |  |
| 13427042 |  | Hall B - Remove |  | 14d | 2012-10-16 | 2012-11-02 | 3A-17M, 13427035 FS-4d | 207d | 0d |  | MECH TECH [480 h]; MECH ENG [108 h] | 29,827.68 | BEVINS M | 1 | 1 | MIKE B |  |  |  |  |  |  |  |  |  |  | 10-065 |  |  |  |  | 12-035 |  |  |  | 08-044 |  | 08-029 |  |  |  |  |  |  |  |  |
| 13427037 |  | Hall A - Upstairs |  | 22d | 2012-10-22 | 2012-11-20 | 13427035 | 186d | 0d |  | MECH TECH [424 h]; MECH ENG [96 h] | 26,391.2 | BEVINS M | 1 | 1 | MIKE B |  |  |  |  |  |  |  |  |  |  | 10-065 |  |  |  |  | 12-035 |  | 11-052 |  |  | 12-028F |  |  |  |  |  |  |  |  |  |
| 13427050 |  | Hall C - Remove |  | 14d | 2012-10-23 | 2012-11-09 | 13427042 FS-9d, 3A-18M | 207d | 0d |  | MECH TECH [144 h]; MECH ENG [32 h] | 8,919.36 | BEVINS M | 1 | 1 | MIKE B |  |  |  |  |  |  |  |  |  |  | 10-065 |  |  |  |  | 12-035 |  |  |  |  |  |  |  |  |  |  |  |  |  |  |
| 13427045 |  | Hall B - Upstairs |  | 44d | 2012-11-05 | 2013-01-15 | 13427042 | 293d | 1d |  | MECH TECH [784 h]; MECH ENG [176 h] | 48,689.6 | BEVINS M | 1 | 1 | MIKE B |  |  |  |  |  |  |  |  |  |  | 10-065 |  |  |  |  | 12-035 |  |  |  |  | 12-028 |  |  |  |  |  |  |  |  |  |
| 13427047 |  | Hall B - Install |  | 88d | 2012-11-05 | 2013-03-20 | 3A-38M, 13427045 FS-45d | 292d | 165d |  | MECH ENG [300 h]; MECH TECH [1336 h] | 82,976.96 | BEVINS M | 1 | 1 | MIKE B |  |  |  |  |  |  |  |  |  |  | 10-065 |  |  |  |  | 12-035 |  |  |  |  | 12-028 |  |  |  |  |  |  |  |  |  |
| 13427040 |  | Hall A - Install |  | 89d | 2012-11-12 | 2013-03-28 | 3A-37M, 13427037 FS-7d | 186d | 138d |  | MECH TECH [488 h]; MECH ENG [108 h] | 30,194.56 | BEVINS M | 1 | 1 | MIKE B |  |  |  |  |  |  |  |  |  |  | 10-065 |  |  |  |  | 12-035 |  |  |  | 08-044 |  | 08-029 |  |  |  |  |  |  |  |  |
| 13427052 |  | Hall C - Upstairs |  | 26d | 2012-11-12 | 2012-12-19 | 13427050 | 328d | 0d |  | MECH TECH [472 h]; MECH ENG [104 h] | 29,171.36 | BEVINS M | 1 | 1 | MIKE B |  |  |  |  |  |  |  |  |  |  | 10-065 |  |  |  |  | 12-035 |  |  |  |  |  |  |  |  |  |  |  |  |  |  |
| 13427057 |  | Hall C - Install |  | 28d | 2012-12-11 | 2013-01-28 | 3A-33M, 13427052 FS-7d | 328d | 205d |  | MECH TECH [528 h]; MECH ENG [120 h] | 32,897.28 | BEVINS M | 1 | 1 | MIKE B |  |  |  |  |  |  |  |  |  |  | 10-065 |  |  |  |  | 12-035 |  |  |  |  |  |  |  |  |  |  |  |  |  |  |
| 13427028 |  | West Arc LCW Work |  | 30d | 2013-01-03 | 2013-02-14 | 9-130M FS+60d | 130d | 0d |  | MECH TECH [436 h] | 19,994.96 | BEVINS M | 1 | 1 | MIKE B |  |  | 08-016 | 09-012 |  |  |  |  |  |  | 10-065 |  |  |  |  | 12-035 | 07-024 | 11-052 | 12-053 |  |  |  | 13-003 |  |  |  |  |  |  |  |
| 13427032 |  | Arcs - Final align east end |  | 18d | 2013-01-22 | 2013-02-14 | 13427027a | 144d | 0d |  | MECH TECH [720 h]; MECH ENG [160 h] | 44,596.8 | BEVINS M | 1 | 1 | MIKE B |  |  |  |  |  |  |  |  |  |  | 10-065 |  |  |  |  | 12-035 |  | 11-052 |  |  | 12-028F |  |  |  |  |  |  |  |  |  |
| 13427030 |  | Arcs - Final align west end |  | 17d | 2013-02-15 | 2013-03-12 | 9-130M, 13417020, 13427028, 13458010, 13458012, 13458040 | 130d | 0d |  | MECH TECH [1384 h]; MECH ENG [312 h] | 86,046.56 | BEVINS M | 1 | 1 | MIKE B |  |  |  |  |  |  |  |  |  |  | 10-065 |  |  |  |  | 12-035 |  | 11-052 |  |  | 12-028F |  |  |  |  |  |  |  |  |  |
| 13427062 |  | SW matching final alignment |  | 4d | 2013-06-27 | 2013-07-02 | 13463050 | 24d | 0d |  | MECH TECH [144 h]; MECH ENG [32 h] | 8,919.36 | BEVINS M | 1 | 1 | MIKE B |  |  |  |  |  |  |  |  |  |  | 10-065 |  |  |  |  | 12-035 |  |  |  |  |  |  |  | 12-018F | 12-029F |  |  |  |  |  |
| 13427061 |  | NE matching final alignment |  | 2d | 2013-08-05 | 2013-08-06 | 13417095 | 24d | 0d |  | MECH TECH [144 h]; MECH ENG [32 h] | 8,919.36 | BEVINS M | 1 | 1 | MIKE B |  |  |  |  |  |  |  |  |  |  | 10-065 |  |  |  |  | 12-035 |  |  |  |  |  |  |  |  |  |  |  |  |  |  |
| 13427185 |  | Re-Baseline Actuals Adjustment |  | 1d | 2013-08-30 | 2013-08-30 | 9-130M FS+227d | 20d |  |  | PROCUREMENT>$50K 69 NO ESCALATION | 20,141.16 | BEVINS M | 1 | 1 | MIKE B |  |  |  |  |  | 13-014 | ADJ |  |  |  |  |  |  |  |  |  |  |  |  |  |  |  |  |  |  |  |  |  |  |  |
| 23427016LOE |  | Installation Team Engineering Support FY13 (12 Month Down) |  | 20d | 2013-09-03 | 2013-09-30 | 9-130M FS+228d | 0d |  | 8/5 M-F w/JLAB Holidays ReBaseline | MECH DES [182.52 h] | 9,073.07 | BEVINS M | 1 | 1 | MIKE B |  |  |  |  |  |  |  |  |  |  | 10-065 |  |  |  |  | 12-035 |  |  |  |  |  |  |  |  |  | 23427016LOE | E | PE | 13-015 | PR |

Notes:
- 13427032: Entry Criteria: Ext Pred: Finish of magnet / measurement
- 13427030: Entry Criteria: Ext Pred: Finish of magnet / measurement

| ID | WBS | Activity | Duration | Start | Finish | Predecessors | Total float | Free float | Calendar | Resources | Cost | Original Activity ID Rebaseline | RESP - Responsibility | STRT%COMP for CM EVM | FNSH%COMP for CM EVM | EVMS Reporting Codes | CAM RESPONSIBLE | CR 08-029 | CR 08-044 | CR 10-065 | CR 12-035 | BOE Labor | CR 13-015 | Post Rebaseline | CR 12-028 | Over Under Fixed | Obligated Prior to Rebaseline | CR 14-001 | CR 09-012 | CR 11-001 | CR 13-014 | ReBaseline Actuals Adjustment | CR 10-030 |
| --- | --- | --- | --- | --- | --- | --- | --- | --- | --- | --- | --- | --- | --- | --- | --- | --- | --- | --- | --- | --- | --- | --- | --- | --- | --- | --- | --- | --- | --- | --- | --- | --- | --- |
| 23427040 |  | Hall A - Install FY13 | 20d | 2013-09-03 | 2013-09-30 | 9-130M FS+228d | 48d | 0d | 8/5 M-F w/JLAB Holidays ReBaseline | MECH TECH [208.34 h]; MECH ENG [50.32 h] | 13,195.55 | 23427040 | BEVINS M | 1 | 1 | S | MIKE B | 08-029 | 08-044 | 10-065 | 12-035 | PE | 13-015 | PR |  |  |  |  |  |  |  |  |  |
| 23427047 |  | Hall B - Install FY13 | 20d | 2013-09-03 | 2013-09-30 | 9-130M FS+228d | 126d | 0d | 8/5 M-F w/JLAB Holidays ReBaseline | MECH ENG [64.48 h]; MECH TECH [264.76 h] | 16,807.64 | 23427047 | BEVINS M | 1 | 1 | S | MIKE B |  |  | 10-065 | 12-035 | PE | 13-015 | PR | 12-028 |  |  |  |  |  |  |  |  |
| 23427052 |  | Hall C - Upstairs FY13 | 20d | 2013-09-03 | 2013-09-30 | 9-130M FS+228d | 122d | 0d | 8/5 M-F w/JLAB Holidays ReBaseline | MECH TECH [118.22 h]; MECH ENG [29.56 h] | 7,560.42 | 23427052 | BEVINS M | 1 | 1 | S | MIKE B |  |  | 10-065 | 12-035 | PE | 13-015 | PR |  |  |  |  |  |  |  |  |  |
| 23427062 |  | Material Handling costs (Vehicle) | 54d | 2013-09-03 | 2013-11-15 | 9-130M FS+228d | 81d | 0d | 8/5 M-F w/JLAB Holidays ReBaseline | PROCUREMENT<$50K 60 NO ESCALATION FY14 | 18,239.39 | 23427057 | BEVINS M | 1 | 1 | S | MIKE B |  |  | 10-065 | 12-035 | PE | 13-015 | PR |  | y | OB |  |  |  |  |  |  |
| 23427016LOEa |  | Installation Team Engineering Support FY14 (12 Month Down) | 34d | 2013-10-01 | 2013-11-15 | 9-130M FS+228d, 23427016LOE | 0d |  | 8/5 M-F w/JLAB Holidays ReBaseline | MECH DES [310.29 h] | 15,917.88 | 23427016LOE | BEVINS M | 1 | 1 | E | MIKE B |  |  | 10-065 | 12-035 | PE | 13-015 | PR |  |  |  | 14-001 |  |  |  |  |  |
| 23427040a |  | Hall A - Install FY14 | 9d | 2013-10-01 | 2013-10-11 | 23427040, 9-130M FS+228d | 48d | 0d | 8/5 M-F w/JLAB Holidays ReBaseline | MECH TECH [93.76 h]; MECH ENG [22.64 h] | 6,127.33 | 23427040 | BEVINS M | 1 | 1 | S | MIKE B | 08-029 | 08-044 | 10-065 | 12-035 | PE | 13-015 | PR |  |  |  | 14-001 |  |  |  |  |  |
| 23427047a |  | Hall B - Install FY14 | 30d | 2013-10-01 | 2013-11-11 | 9-130M FS+228d, 23427047 | 126d | 0d | 8/5 M-F w/JLAB Holidays ReBaseline | MECH ENG [96.72 h]; MECH TECH [397.15 h] | 26,015.23 | 23427047 | BEVINS M | 1 | 1 | S | MIKE B |  |  | 10-065 | 12-035 | PE | 13-015 | PR | 12-028 |  |  | 14-001 |  |  |  |  |  |
| 23427052a |  | Hall C - Upstairs FY14 | 7d | 2013-10-01 | 2013-10-09 | 9-130M FS+228d, 23427052 | 122d | 0d | 8/5 M-F w/JLAB Holidays ReBaseline | MECH TECH [41.38 h]; MECH ENG [10.34 h] | 2,730.3 | 23427052 | BEVINS M | 1 | 1 | S | MIKE B |  |  | 10-065 | 12-035 | PE | 13-015 | PR |  |  |  | 14-001 |  |  |  |  |  |
| 23427057 |  | Hall C - Install | 27d | 2013-10-10 | 2013-11-15 | 23427052, 23427052a | 122d | 0d | 8/5 M-F w/JLAB Holidays ReBaseline | MECH TECH [546 h]; MECH ENG [132 h] | 35,693.16 | 23427057 | BEVINS M | 1 | 1 | S | MIKE B |  |  | 10-065 | 12-035 | PE | 13-015 | PR |  |  |  | 14-001 |  |  |  |  |  |
| 23427067 |  | Material Handling costs DeObligation | 1d | 2013-11-18 | 2013-11-18 | 23427062 | 81d | 63d | 8/5 M-F w/JLAB Holidays ReBaseline | PROCUREMENT<$50K 60 | -10,319 | 23427057 | BEVINS M | 1 | 1 | S | MIKE B |  |  | 10-065 | 12-035 | PE | 13-015 | PR |  |  |  | 14-001 |  |  |  |  |  |
|  | 3 | **1.3.4.3 LINACS** |  | 2009-12-17 | 2013-08-30 |  |  |  |  |  |  |  |  |  |  |  |  |  |  |  |  |  |  |  |  |  |  |  |  |  |  |  |  |
|  | 1 | **1.3.4.3.1 QUADRUPOLES** |  |  |  |  |  |  |  |  |  |  |  |  |  |  |  |  |  |  |  |  |  |  |  |  |  |  |  |  |  |  |  |
|  | 2 | **1.3.4.3.2 CORRECTORS** |  | 2009-12-17 | 2013-08-30 |  |  |  |  |  |  |  |  |  |  |  |  |  |  |  |  |  |  |  |  |  |  |  |  |  |  |  |  |
| 13432005 |  | Vend Fab H & V Linac Correctors (Linac Correctors) Labor FY10 | 195d | 2009-12-17 | 2010-09-30 | 121434999, 121432005, 13432004b | 302d | 0d |  | MECH DES [29.88 h]; MECH ENG [29.88 h] | 3,319.37 |  | BEVINS M | 1 | 1 |  | MIKE B | 08-029 |  |  |  |  |  |  |  |  |  |  | 09-012 | 11-001 |  |  |  |
| 13432005b |  | Vend Fab H & V Linac Correctors (Linac Correctors) Procurement | 261d | 2009-12-17 | 2011-01-12 | 121434999, 13432004b, 121432005 | 302d | 64d |  | PROCUREMENT<$50K 60 NO ESCALATION FY11 | 20,595.41 |  | BEVINS M | 1 | 1 |  | MIKE B | 08-029 |  |  |  |  |  |  |  |  |  |  | 09-012 | 11-001 |  |  |  |
| 13432005a |  | Vend Fab H & V Linac Correctors (Linac Correctors) Labor FY11 | 66d | 2010-10-01 | 2011-01-12 | 13432005 | 302d | 64d |  | MECH ENG [10.12 h]; MECH DES [10.12 h] | 1,160.05 |  | BEVINS M | 1 | 1 |  | MIKE B | 08-029 |  |  |  |  |  |  |  |  |  |  | 09-012 | 11-001 |  |  |  |
| 13432015 |  | Mag Measurement of Linac Correctors & Skew Quads (Linac Correctors) | 30d | 2011-04-15 | 2011-05-26 | 13432005b, 13432005a, 9-110M FS+130d | 238d |  |  | MECH TECH [164 h]; MECH ENG [8 h] | 7,607.08 |  | BEVINS M | 1 | 1 |  | MIKE B |  |  |  |  |  |  |  |  |  |  |  |  |  |  |  |  |
| 13432020 |  | Re-Baseline Actuals Adjustment | 1d | 2013-08-30 | 2013-08-30 | 9-130M FS+227d | 20d |  |  | PROCUREMENT>$50K 69 NO ESCALATION | 11,763.44 |  | BEVINS M | 1 | 1 |  | MIKE B |  |  |  |  |  |  |  |  |  |  |  |  |  | 13-014 | ADJ |  |
|  | 3 | **1.3.4.3.3 STANDS** |  | 2010-08-16 | 2013-08-30 |  |  |  |  |  |  |  |  |  |  |  |  |  |  |  |  |  |  |  |  |  |  |  |  |  |  |  |  |
| 13434005 |  | Proc Prep Linac Girders (Linac Girders) FY10 | 33d | 2010-08-16 | 2010-09-30 | 121434005, 9-100M FS+215d, 121434999 | 54d | 0d |  | MECH ENG [44.75 h]; MECH DES [44.75 h] | 4,971.28 |  | BEVINS M | 1 | 1 |  | MIKE B |  |  | 10-065 |  |  |  |  |  |  |  |  |  | 11-001 |  |  | 10-030 |
| 13433005 |  | Proc Prep Linac Stands (Linac Stands) | 43d | 2010-10-01 | 2010-12-02 | 121434999, 121434005, 9-110M | 55d | 0d |  | MECH DES [20 h]; MECH ENG [80 h] | 6,369.6 |  | BEVINS M | 1 | 1 |  | MIKE B |  |  | 10-065 |  |  |  |  |  |  |  |  |  |  |  |  | 10-030 |
| 13434005a |  | Proc Prep Linac Girders (Linac Girders) FY11 | 26d | 2010-10-01 | 2010-11-05 | 13434005 | 54d | 0d |  | MECH DES [35.25 h]; MECH ENG [35.25 h] | 4,040.71 |  | BEVINS M | 1 | 1 |  | MIKE B |  |  | 10-065 |  |  |  |  |  |  |  |  |  | 11-001 |  |  | 10-030 |
| 13434006 |  | Vend Fab Linac Girders (Linac Girders) | 70d | 2010-11-08 | 2011-02-25 | 13434005a | 54d | 0d |  | PROCUREMENT<$50K 60 | 92,871 |  | BEVINS M | 1 | 1 |  | MIKE B |  |  | 10-065 |  |  |  |  |  |  |  |  |  |  |  |  | 10-030 |
| 13433010 |  | Vend Fab Linac Stands (Linac Stands) | 52d | 2010-12-03 | 2011-02-24 | 13433005 | 55d | 0d |  | PROCUREMENT<$50K 60 | 14,962.55 |  | BEVINS M | 1 | 1 |  | MIKE B |  |  | 10-065 |  |  |  |  |  |  |  |  |  |  |  |  | 10-030 |
| 13433015 |  | Receive and Inspect Linac Stands (Linac Stands) | 9d | 2011-02-11 | 2011-02-24 | 13433010 FS-9d | 55d |  |  | MECH TECH [40 h] | 1,722.8 |  | BEVINS M | 1 | 1 |  | MIKE B |  |  | 10-065 |  |  |  |  |  |  |  |  |  |  |  |  | 10-030 |
| 13434007 |  | Receive and Inspect Linac Girders (Linac Girders) | 9d | 2011-02-14 | 2011-02-25 | 13434006 FS-9d | 54d |  |  | MECH TECH [8 h] | 344.56 |  | BEVINS M | 1 | 1 |  | MIKE B |  |  | 10-065 |  |  |  |  |  |  |  |  |  |  |  |  | 10-030 |
| 13433020 |  | Re-Baseline Actuals Adjustment | 1d | 2013-08-30 | 2013-08-30 | 9-130M FS+227d | 20d |  |  | PROCUREMENT>$50K 69 NO ESCALATION | 2,268.37 |  | BEVINS M | 1 | 1 |  | MIKE B |  |  |  |  |  |  |  |  |  |  |  |  |  | 13-014 | ADJ |  |

| ID | WBS | Activity | Duration | Start | Finish | Predecessors | Total float | Free float | Resources | Cost | RESP - Responsibility | STRT%COMP for CM EVM | FNSH%COMP for CM EVM | CAM RESPONSIBLE | CR 10-030 | CR 10-065 | CR 08-016 | CR 09-012 | CR 13-014 | ReBaseline Actuals Adjustment | Activities with Steps | CR 11-012 | CR 12-035 | CR 13-003 | CR 08-029 | CR 10-001 | CR 11-001 |
| --- | --- | --- | --- | --- | --- | --- | --- | --- | --- | --- | --- | --- | --- | --- | --- | --- | --- | --- | --- | --- | --- | --- | --- | --- | --- | --- | --- |
|  | 4 | **1.3.4.3.4 GIRDERS** |  |  |  |  |  |  |  |  |  |  |  |  |  |  |  |  |  |  |  |  |  |  |  |  |  |
|  | 5 | **1.3.4.3.5 VACUUM** |  | 2010-09-17 | 2013-08-30 |  |  |  |  |  |  |  |  |  |  |  |  |  |  |  |  |  |  |  |  |  |  |
| 13435010 |  | Proc New DI Ion Pumps (Linac Vac) | 100d | 2010-09-17 | 2011-02-16 | 9-110M FS-10d | 308d |  | PROCUREMENT<$50K 60 NO ESCALATION FY11 | 21,316.43 | BEVINS M | 1 | 1 | MIKE B | 10-030 | 10-065 |  |  |  |  |  |  |  |  |  |  |  |
| 13435015 |  | Rebuild 3 South Linac Girders (Linac Vac) | 6d | 2011-05-23 | 2011-05-31 | 13436020 | 60d | 0d | MECH TECH [210 h]; MECH DES [20 h]; PROCUREMENT<$50K 60; MECH ENG [10 h] | 11,276.94 | BEVINS M | 1 | 1 | MIKE B | 10-030 | 10-065 | 08-016 | 09-012 |  |  |  |  |  |  |  |  |  |
| 13435020 |  | Re-Baseline Actuals Adjustment | 1d | 2013-08-30 | 2013-08-30 | 9-130M FS+227d | 20d |  | PROCUREMENT>$50K 69 NO ESCALATION | -6,040.98 | BEVINS M | 1 | 1 | MIKE B |  |  |  |  | 13-014 | ADJ |  |  |  |  |  |  |  |
|  | 6 | **1.3.4.3.6 INSTALLATION** |  | 2011-05-13 | 2013-08-30 |  |  |  |  |  |  |  |  |  |  |  |  |  |  |  |  |  |  |  |  |  |  |
| 13436020 |  | Remove Warm Girder SL22 | 6d | 2011-05-13 | 2011-05-20 | 4A-01M | 60d | 0d | MECH TECH [80 h] | 3,445.6 | BEVINS M | 1 | 1 | MIKE B |  | 10-065 |  |  |  |  | NB |  |  |  |  |  |  |
| 13436025 |  | Reinstall Warm Girder SL22 | 6d | 2011-06-01 | 2011-06-08 | 131501000 FS+1d, 13435015 | 60d | 0d | MECH TECH [120 h] | 5,168.4 | BEVINS M | 1 | 1 | MIKE B |  | 10-065 |  |  |  |  | NB |  |  |  |  |  |  |
| 13436030 |  | Remove Warm Girder SL23 | 6d | 2011-06-09 | 2011-06-16 | 13436025 | 60d | 23d | MECH TECH [80 h] | 3,445.6 | BEVINS M | 1 | 1 | MIKE B |  | 10-065 |  |  |  |  | NB |  |  |  |  |  |  |
| 13436035 |  | Reinstall Warm Girder SL23 | 6d | 2011-07-28 | 2011-08-04 | 131502000 | 37d | 25d | MECH TECH [120 h] | 5,168.4 | BEVINS M | 1 | 1 | MIKE B |  | 10-065 |  |  |  |  | NB | 11-012 |  |  |  |  |  |
| 13436040 |  | SL - remove girders | 10d | 2012-05-21 | 2012-06-05 | 2-02M FS+5d | 38d | 0d | MECH ENG [128 h]; MECH TECH [176 h] | 16,796.8 | BEVINS M | 1 | 1 | MIKE B |  | 10-065 |  |  |  |  |  |  | 12-035 |  |  |  |  |
| 13436050 |  | SL - rebuild girders | 1d | 2012-05-22 | 2012-05-22 | 2-02M FS+5d, 13436040 FS-9d | 38d | 3d | MECH TECH [16 h]; MECH ENG [12 h] | 1,552.48 | BEVINS M | 1 | 1 | MIKE B |  | 10-065 |  |  |  |  |  |  | 12-035 |  |  |  |  |
| 13436045 |  | NL - remove girders | 19d | 2012-06-06 | 2012-07-02 | 13436040 | 149d | 0d | MECH TECH [312 h]; MECH ENG [224 h] | 29,572.16 | BEVINS M | 1 | 1 | MIKE B |  | 10-065 |  |  |  |  |  |  | 12-035 |  |  |  |  |
| 13436055 |  | NL - rebuild girders | 16d | 2012-07-03 | 2012-07-24 | 13436045 | 149d | 104d | MECH TECH [192 h]; MECH ENG [140 h] | 18,349.28 | BEVINS M | 1 | 1 | MIKE B |  | 10-065 |  |  |  |  |  |  | 12-035 |  |  |  |  |
| 13436060 |  | SL final alignment | 9d | 2013-04-11 | 2013-04-23 | 13417045 | 58d | 34d | MECH TECH [360 h]; MECH ENG [80 h] | 22,298.4 | BEVINS M | 1 | 1 | MIKE B |  | 10-065 |  |  |  |  |  |  | 12-035 | 13-003 |  |  |  |
| 13436065 |  | NL final alignment | 9d | 2013-07-16 | 2013-07-26 | 13417070 | 24d | 0d | MECH TECH [360 h]; MECH ENG [80 h] | 22,298.4 | BEVINS M | 1 | 1 | MIKE B |  | 10-065 |  |  |  |  |  |  | 12-035 |  |  |  |  |
| 13436070 |  | Re-Baseline Actuals Adjustment | 1d | 2013-08-30 | 2013-08-30 | 9-130M FS+227d | 20d |  | PROCUREMENT>$50K 69 NO ESCALATION | -9,788.69 | BEVINS M | 1 | 1 | MIKE B |  |  |  |  | 13-014 | ADJ |  |  |  |  |  |  |  |
|  | 4 | **1.3.4.4 INJECTOR & RE-INJECTION** |  | 2009-01-02 | 2013-09-17 |  |  |  |  |  |  |  |  |  |  |  |  |  |  |  |  |  |  |  |  |  |  |
|  | 1 | **1.3.4.4.1 DIPOLES** |  | 2009-07-02 | 2013-08-30 |  |  |  |  |  |  |  |  |  |  |  |  |  |  |  |  |  |  |  |  |  |  |
| 13441004 |  | Proc Prep for Chicane Dipoles (INJ/REINJ Dipoles) FY09 | 63d | 2009-07-02 | 2009-09-30 | 9-090M FS+185d | 312d | 0d | MECH DES [28.24 h]; MECH ENG [28.24 h] | 3,040.03 | BEVINS M | 1 | 1 | MIKE B |  |  |  |  |  |  |  |  |  |  | 08-029 | 10-001B |  |
| 13441004b |  | Proc Prep for Chicane Dipoles (INJ/REINJ Dipoles) FY10 | 53d | 2009-10-01 | 2009-12-16 | 13441004 | 312d | 0d | MECH DES [23.76 h]; MECH ENG [23.76 h] | 2,639.5 | BEVINS M | 1 | 1 | MIKE B |  |  |  |  |  |  |  |  |  |  |  | 10-001B |  |
| 13441005 |  | Vend Fab New Chicane Dipoles (INJ/REINJ Dipoles) FY10 | 195d | 2009-12-17 | 2010-09-30 | 13441004b, 121441010a | 312d | 0d | MECH ENG [161.38 h]; MECH DES [11.95 h] | 11,167.49 | BEVINS M | 1 | 1 | MIKE B |  |  |  | 09-012 |  |  |  |  |  |  | 08-029 |  | 11-001 |
| 13441005b |  | Vend Fab New Chicane Dipoles (INJ/REINJ Dipoles) Procurement | 261d | 2009-12-17 | 2011-01-12 | 121441010a, 13441004b | 312d | 64d | PROCUREMENT<$50K 60 NO ESCALATION FY11 | 38,889.68 | BEVINS M | 1 | 1 | MIKE B |  |  |  | 09-012 |  |  |  |  |  |  | 08-029 |  | 11-001 |
| 13441005a |  | Vend Fab New Chicane Dipoles (INJ/REINJ Dipoles) FY11 | 66d | 2010-10-01 | 2011-01-12 | 13441005 | 312d | 64d | MECH ENG [54.62 h]; MECH DES [4.05 h] | 3,900.48 | BEVINS M | 1 | 1 | MIKE B |  |  |  | 09-012 |  |  |  |  |  |  | 08-029 |  | 11-001 |
| 13441010 |  | Mag Measurement of Chicane Dipoles (INJ/REINJ Dipoles) | 20d | 2011-04-15 | 2011-05-12 | 13441005b, 13441005a, 9-110M FS+130d | 248d |  | MECH ENG [12 h]; MECH TECH [20 h] | 1,676.8 | BEVINS M | 1 | 1 | MIKE B |  |  |  |  |  |  |  |  |  |  | 08-029 |  |  |
| 13441015 |  | Re-Baseline Actuals Adjustment | 1d | 2013-08-30 | 2013-08-30 | 9-130M FS+227d | 20d |  | PROCUREMENT>$50K 69 NO ESCALATION | -28,930.61 | BEVINS M | 1 | 1 | MIKE B |  |  |  |  | 13-014 | ADJ |  |  |  |  |  |  |  |

Notes:
- 13436020: Explanation: Successor to be installation of Cryo Module #1 once built / on Hogan ETC CR10-064
- 13436025: Explanation: Successor to be commiss ioningof Cryo Module 1 / once built on Hogan ETC CR10-064
- 13436030: Explanation: Successor to be installation of Cryo Module #2 once built / on Hogan ETC CR10-064
- 13436035: Explanation: Successor to be commiss ioningof Cryo Module #2 once / built on Hogan ETC CR10-064

| ID | WBS | Activity | Duration | Start | Finish | Predecessors | Total float | Free float | Calendar | Resources | Cost | RESP - Responsibility | STRT%COMP for CM EVM | FNSH%COMP for CM EVM | CAM RESPONSIBLE | CR 08-058 | CR 10-030 | CR 12-035 | CR 10-065 | CR 11-057 | CR 13-014 | ReBaseline Actuals Adjustment | Profile change | CR 12-053 | Original Activity ID Rebaseline | EVMS Reporting Codes | BOE Labor | CR 13-015 | Post Rebaseline |
| --- | --- | --- | --- | --- | --- | --- | --- | --- | --- | --- | --- | --- | --- | --- | --- | --- | --- | --- | --- | --- | --- | --- | --- | --- | --- | --- | --- | --- | --- |
|  | 2 | **1.3.4.4.2 QUADRUPOLES** |  |  |  |  |  |  |  |  |  |  |  |  |  |  |  |  |  |  |  |  |  |  |  |  |  |  |  |
|  | 3 | **1.3.4.4.3 CORRECTORS** |  |  |  |  |  |  |  |  |  |  |  |  |  |  |  |  |  |  |  |  |  |  |  |  |  |  |  |
|  | 4 | **1.3.4.4.4 STANDS** |  | 2009-01-02 | 2013-08-30 |  |  |  |  |  |  |  |  |  |  |  |  |  |  |  |  |  |  |  |  |  |  |  |  |
| 13444909LOE |  | FY09 Mngmnt/Planning for Reinjection Modifications (INJ/RE-INJ Stands) | 189d | 2009-01-02 | 2009-09-30 | 13444909LOEXD | 20d | 0d |  | SR STAFF [152.42 h]; MECH DES [121.94 h] | 21,020.72 | BEVINS M | 1 | 1 | MIKE B | 08-058 |  |  |  |  |  |  |  |  |  |  |  |  |  |
| 13445005 |  | Proc/Vend Fab New Girder for Chicane (INJ/RE-INJ Girders) | 61d | 2010-08-12 | 2010-11-05 | 9-100M FS+213d | 372d |  |  | PROCUREMENT<$50K 60 NO ESCALATION FY11 | 14,723.73 | BEVINS M | 1 | 1 | MIKE B |  | 10-030 |  |  |  |  |  |  |  |  |  |  |  |  |
| 13444020 |  | Proc Alignment Cartridges (INJ/RE-INJ Stands) | 100d | 2010-12-07 | 2011-05-05 | 121444015, 9-110M FS+45d | 253d |  |  | MECH DES [8 h]; PROCUREMENT<$50K 60 | 1,393.9 | BEVINS M | 1 | 1 | MIKE B |  |  |  |  |  |  |  |  |  |  |  |  |  |  |
| 13444025 |  | Procurem/Vend Fab Modifications for Spectrometer (INJ/RE-INJ Stands) | 130d | 2010-12-07 | 2011-06-17 | 9-110M FS+45d, 121444020 | 223d |  |  | MECH TECH [40 h]; MECH ENG [80 h]; MECH DES [160 h]; PROCUREMENT<$50K 60 | 48,642.7 | BEVINS M | 1 | 1 | MIKE B |  |  |  |  |  |  |  |  |  |  |  |  |  |  |
| 13444015 |  | Proc Prep New ReInjection Stands (INJ/RE-INJ Stands) | 44d | 2011-06-15 | 2011-08-16 | 9-110M FS+172d, 121444015 | 155d | 98d |  | MECH DES [36 h]; MECH ENG [48 h] | 4,942.08 | BEVINS M | 1 | 1 | MIKE B |  | 10-030 | 12-035F |  |  |  |  |  |  |  |  |  |  |  |
| 13444017 |  | Vend Fab New ReInjection Stands (INJ/RE-INJ Stands) | 71d | 2012-01-13 | 2012-04-24 | 13444015, 9-120M FS+66d | 57d | 0d |  | PROCUREMENT<$50K 60 | 6,388.91 | BEVINS M | 1 | 1 | MIKE B |  | 10-030 | 12-035F | 10-065 | 11-057 |  |  |  |  |  |  |  |  |  |
| 13444018 |  | Receive and Inspect New ReInjection Stands (INJ/RE-INJ Stands) | 10d | 2012-04-11 | 2012-04-24 | 13444017 FS-10d | 57d | 27d |  | MECH TECH [16 h] | 711.04 | BEVINS M | 1 | 1 | MIKE B |  | 10-030 | 12-035F | 10-065 | 11-057 |  |  |  |  |  |  |  |  |  |
| 13444950 |  | Re-Baseline Actuals Adjustment | 1d | 2013-08-30 | 2013-08-30 | 9-130M FS+227d | 20d |  |  | PROCUREMENT>$50K 69 NO ESCALATION | -986.18 | BEVINS M | 1 | 1 | MIKE B |  |  |  |  |  | 13-014 | ADJ |  |  |  |  |  |  |  |
|  | 5 | **1.3.4.4.5 GIRDERS** |  |  |  |  |  |  |  |  |  |  |  |  |  |  |  |  |  |  |  |  |  |  |  |  |  |  |  |
|  | 6 | **1.3.4.4.6 VACUUM** |  | 2011-04-08 | 2013-08-30 |  |  |  |  |  |  |  |  |  |  |  |  |  |  |  |  |  |  |  |  |  |  |  |  |
| 13446010 |  | Proc Prep New Vac Chambers (INJ/RE-INJ Vac) | 44d | 2011-04-08 | 2011-06-09 | 9-110M FS+125d, 121446005, 121446999 | 161d | 109d |  | MECH DES [40 h]; MECH ENG [80 h] | 7,303.2 | BEVINS M | 1 | 1 | MIKE B |  | 10-030 |  |  | 11-057 |  |  | C |  |  |  |  |  |  |
| 13446010a |  | Vend Fab New Vac Chambers (INJ/RE-INJ Vac) | 68d | 2011-11-14 | 2012-02-29 | 9-120M FS+30d, 13446010 | 52d | 0d |  | PROCUREMENT<$50K 60 | 5,856.5 | BEVINS M | 1 | 1 | MIKE B |  | 10-030 |  |  | 11-057 |  |  | C |  |  |  |  |  |  |
| 13446010b |  | Receive and Inspect New Vac Chambers (INJ/RE-INJ Vac) | 10d | 2012-02-15 | 2012-02-29 | 13446010a FS-10d | 52d |  |  | MECH ENG [8 h]; MECH TECH [8 h] | 916.48 | BEVINS M | 1 | 1 | MIKE B |  | 10-030 |  |  | 11-057 |  |  | C |  |  |  |  |  |  |
| 13446015 |  | Re-Baseline Actuals Adjustment | 1d | 2013-08-30 | 2013-08-30 | 9-130M FS+227d | 20d |  |  | PROCUREMENT>$50K 69 NO ESCALATION | -6,126.26 | BEVINS M | 1 | 1 | MIKE B |  |  |  |  |  | 13-014 | ADJ |  |  |  |  |  |  |  |
|  | 7 | **1.3.4.4.7 INSTALLATION** |  | 2012-06-05 | 2013-09-17 |  |  |  |  |  |  |  |  |  |  |  |  |  |  |  |  |  |  |  |  |  |  |  |  |
| 13447005 |  | 45 MeV Dump - Remove | 4d | 2012-06-05 | 2012-06-08 | 13444018, 2-02M FS+14d | 30d | 0d |  | MECH TECH [104 h]; MECH ENG [76 h] | 9,950.88 | BEVINS M | 1 | 1 | MIKE B |  |  | 12-035 | 10-065 |  |  |  |  |  |  |  |  |  |  |
| 13447015 |  | OL/OR - Remove | 11d | 2012-09-07 | 2012-09-21 | 13417050M | 78d | 0d |  | MECH TECH [360 h]; MECH ENG [260 h] | 34,229.6 | BEVINS M | 1 | 1 | MIKE B |  |  | 12-035 | 10-065 |  |  |  |  |  |  |  |  |  |  |
| 13447025 |  | OL/OR - Upstairs | 8d | 2012-09-17 | 2012-09-26 | 13447015 FS-5d | 85d | 7d |  | MECH ENG [140 h]; MECH TECH [192 h] | 18,349.28 | BEVINS M | 1 | 1 | MIKE B |  |  | 12-035 | 10-065 |  |  |  |  |  |  |  |  |  |  |
| 13447020 |  | OL/OR - Install stands FY12 | 5d | 2012-09-24 | 2012-09-28 | 13447015 | 78d | 0d |  | MECH ENG [86 h]; MECH TECH [180 h] | 14,029.52 | BEVINS M | 1 | 1 | MIKE B |  |  | 12-035 | 10-065 |  |  |  |  | 12-053 |  |  |  |  |  |
| 13447020a |  | OL/OR - Install stands FY13 | 5d | 2012-10-01 | 2012-10-05 | 13447020 | 78d | 0d |  | MECH ENG [86 h]; MECH TECH [180 h] | 14,477.76 | BEVINS M | 1 | 1 | MIKE B |  |  | 12-035 | 10-065 |  |  |  |  | 12-053 |  |  |  |  |  |
| 13447030 |  | OL/OR - Install magnets and girders | 21d | 2012-10-08 | 2012-11-05 | 13447025, 13447020a | 78d | 0d |  | MECH TECH [664 h]; MECH ENG [148 h] | 41,160.32 | BEVINS M | 1 | 1 | MIKE B |  |  | 12-035 | 10-065 |  |  |  |  |  |  |  |  |  |  |
| 13447035 |  | OL/OR - Final align | 10d | 2012-11-06 | 2012-11-19 | 13447030 | 78d | 0d |  | MECH ENG [44 h]; MECH TECH [200 h] | 12,355.84 | BEVINS M | 1 | 1 | MIKE B |  |  | 12-035 | 10-065 |  |  |  |  |  |  |  |  |  |  |
| 13447010 |  | 45 MeV Dump - Re-install | 6d | 2013-07-25 | 2013-08-01 | 13447005 FS+280d | 30d |  |  | MECH TECH [104 h]; MECH ENG [24 h] | 6,506.08 | BEVINS M | 1 | 1 | MIKE B |  |  | 12-035 | 10-065 |  |  |  |  |  |  |  |  |  |  |
| 13447040 |  | Re-Baseline Actuals Adjustment | 1d | 2013-08-30 | 2013-08-30 | 9-130M FS+227d | 20d |  |  | PROCUREMENT>$50K 69 NO ESCALATION | -5,188.41 | BEVINS M | 1 | 1 | MIKE B |  |  |  |  |  | 13-014 | ADJ |  |  |  |  |  |  |  |
| 23447010 |  | 45 MeV Dump - Re-install | 11d | 2013-09-03 | 2013-09-17 | 9-130M FS+228d | 3d |  | 8/5 M-F w/JLAB Holidays ReBaseline | MECH TECH [256 h]; MECH ENG [64 h] | 16,371.2 | BEVINS M | 1 | 1 | MIKE B |  |  | 12-035 | 10-065 |  |  |  |  |  | 23447010 | S | PE | 13-015 | PR |

| ID | WBS | Activity | Type | Duration | Start | Finish | Predecessors | Total float | Free float | Resources | Cost | RESP - Responsibility | STRT%COMP for CM EVM | FNSH%COMP for CM EVM | CAM RESPONSIBLE | CR 08-029 | CR 08-058 | CR 10-065 | Milestone Level | CR 09-033 | CR 09-033 Repair | Advance Purchase Plan > 500K | CR 08-016 | 12 GEV MAJOR PROCUREMENT CATAGORY | CR 09-012 | CR 10-001 | Inter Project Link (IPL) | CR 10-003 | CR 11-001 | CR 10-030 | Profile change | CR 12-001 | CR 13-014 | ReBaseline Actuals Adjustment |
| --- | --- | --- | --- | --- | --- | --- | --- | --- | --- | --- | --- | --- | --- | --- | --- | --- | --- | --- | --- | --- | --- | --- | --- | --- | --- | --- | --- | --- | --- | --- | --- | --- | --- | --- |
|  | 5 | **1.3.4.5 ARC 10 & HALL D BEAMLINE** |  |  | 2009-01-02 | 2013-10-23 |  |  |  |  |  |  |  |  |  |  |  |  |  |  |  |  |  |  |  |  |  |  |  |  |  |  |  |  |
|  | 1 | **1.3.4.5.1 DIPOLES** |  |  | 2009-01-02 | 2013-08-30 |  |  |  |  |  |  |  |  |  |  |  |  |  |  |  |  |  |  |  |  |  |  |  |  |  |  |  |  |
| 13451055 |  | Prcrmnt Prep of 4m Dipls (ARC10/H-D Dipl) |  | 7d | 2009-01-02 | 2009-01-12 | 13451055XD | 117d | 0d | MECH ENG [5.09 h]; MECH DES [3.39 h] | 473.41 | BEVINS M | 1 | 1 | MIKE B | 08-029 | 08-058 |  |  |  |  |  |  |  |  |  |  |  |  |  |  |  |  |  |
| 13451909LOE |  | FY09 Mngmnt & Oversight (ARC10/H-D Dipl) |  | 189d | 2009-01-02 | 2009-09-30 | 13451909LOEXD | 20d | 0d | SR STAFF [152.42 h]; TRAVEL | 21,079.42 | BEVINS M | 1 | 1 | MIKE B |  | 08-058 |  |  |  |  |  |  |  |  |  |  |  |  |  |  |  |  |  |
| 13451075 |  | Prcrmnt Prep for 2m Pass 6 Dipole (ARC10/H-D Dipl) |  | 117d | 2009-01-12 | 2009-06-26 | 121451035, 9-090M FS+65d, 121456999 | 270d | 0d | MECH ENG [40 h]; MECH DES [36 h] | 4,130.64 | BEVINS M | 1 | 1 | MIKE B | 08-029 |  | 10-065 |  |  |  |  |  |  |  |  |  |  |  |  |  |  |  |  |
| 13451060M |  | Award Contract for 4m Dipl (ARC10/H-D Dipl) | milestone | 0d | 2009-01-12 | 2009-01-12 | 13451055 | 117d | 0d |  |  | BEVINS M | 1 | 1 | MIKE B | 08-029 |  |  | 6 | 09-033 | 09-033 |  |  |  |  |  |  |  |  |  |  |  |  |  |
| 13451065 |  | FY09 LABOR Oversight 4m Dipl Contract (ARC10/H-D Dipl) |  | 182d | 2009-01-13 | 2009-09-30 | 13451060M | 259d | 0d | MECH DES [41.1 h]; MECH ENG [114.48 h] | 9,106.87 | BEVINS M | 1 | 1 | MIKE B | 08-029 |  | 10-065 |  | 09-033 | 09-033 | APP | 08-016 | 3451 | 09-012 |  |  |  |  |  |  |  |  |  |
| 13451080M |  | Award Contract for 2m Pass 6 Dipole (ARC10/H-D Dipl) | milestone | 0d | 2009-06-26 | 2009-06-26 | 13451075 | 270d | 0d |  |  | BEVINS M | 1 | 1 | MIKE B | 08-029 |  | 10-065 | 6 |  |  |  |  |  |  |  |  |  |  |  |  |  |  |  |
| 13451085 |  | P-1 Vend Fab 2m Pass 6 Dipole (ARC10/H-D Dipl) Labor FY09 |  | 66d | 2009-06-29 | 2009-09-30 | 13451080M | 270d | 0d | MECH DES [11.71 h]; MECH ENG [27.68 h] | 2,279.63 | BEVINS M | 1 | 1 | MIKE B | 08-029 |  | 10-065 |  |  |  |  | 08-016 |  | 09-012 | 10-001B |  |  |  |  |  |  |  |  |
| 13451063a |  | PROC 4m Dpl Cntr PP3a for Coil Material (ARC10/H-D Dipl) |  | 65d | 2009-06-30 | 2009-09-30 | 13451060M FS+117d | 486d | 59d | PROCUREMENT<$50K 60; PROCUREMENT>$50K 69 | 168,436 | BEVINS M | 1 | 1 | MIKE B | 08-029 |  | 10-065 |  | 09-033 | 09-033 | APP | 08-016 | 3451 | 09-012 |  |  |  |  |  |  |  |  |  |
| 13451063b |  | PROC 4m Dpl Cntr PP3b for Core Material (ARC10/H-D Dipl) |  | 44d | 2009-06-30 | 2009-08-31 | 13451060M FS+117d | 507d | 80d | PROCUREMENT>$50K 69; PROCUREMENT<$50K 60 | 615,565 | BEVINS M | 1 | 1 | MIKE B | 08-029 |  | 10-065 |  | 09-033 | 09-033 | APP | 08-016 | 3451 | 09-012 |  |  |  |  |  |  |  |  |  |
| 13451063c |  | PROC 4m Dipl Cntr PP3c for 1st Article Coil Set (ARC10/H-D Dipl) |  | 106d | 2009-06-30 | 2009-11-30 | 13451060M FS+117d | 445d | 18d | PROCUREMENT<$50K 60 NO ESCALATION; PROCUREMENT>$50K 69 NO ESCALATION | 3,856 | BEVINS M | 1 | 1 | MIKE B | 08-029 |  | 10-065 |  | 09-033 | 09-033 | APP | 08-016 | 3451 | 09-012 | 10-001A |  |  |  |  |  |  |  |  |
| 13451063d |  | PROC 4m Dipl Cntr PP3d for 1st Article Core Set (ARC10/H-D Dipl) |  | 124d | 2009-06-30 | 2009-12-31 | 13451060M FS+117d | 427d | 0d | PROCUREMENT>$50K 69 NO ESCALATION; PROCUREMENT<$50K 60 NO ESCALATION | 23,537 | BEVINS M | 1 | 1 | MIKE B | 08-029 |  | 10-065 |  | 09-033 | 09-033 | APP | 08-016 | 3451 | 09-012 | 10-001A |  |  |  |  |  |  |  |  |
| 13451063e-1 |  | PROC 4m Dipl Cntr PP3e-1 Deliver 6 Magnets (ARC10/H-D Dipl) |  | 162d | 2009-06-30 | 2010-02-26 | 13451060M FS+117d | 389d | 209d | PROCUREMENT>$50K 69 NO ESCALATION; PROCUREMENT<$50K 60 NO ESCALATION | 164,358 | BEVINS M | 1 | 1 | MIKE B | 08-029 |  | 10-065 |  | 09-033 | 09-033 | APP | 08-016 | 3451 | 09-012 | 10-001A |  |  |  |  |  |  |  |  |
| 13451063e-2 |  | PROC 4m Dipl Cntr PP3e-2 Deliver 10 Magnets (ARC10/H-D Dipl) |  | 207d | 2009-06-30 | 2010-04-30 | 13451060M FS+117d | 344d | 164d | PROCUREMENT<$50K 60 NO ESCALATION; PROCUREMENT>$50K 69 NO ESCALATION | 273,930 | BEVINS M | 1 | 1 | MIKE B | 08-029 |  | 10-065 |  | 09-033 | 09-033 | APP | 08-016 | 3451 | 09-012 | 10-001A |  |  |  |  |  |  |  |  |
| 13451063e-3 |  | PROC 4m Dipl Cntr PP3e-3 Deliver 10 Magnets (ARC10/H-D Dipl) |  | 249d | 2009-06-30 | 2010-06-30 | 13451060M FS+117d | 302d | 122d | PROCUREMENT<$50K 60 NO ESCALATION; PROCUREMENT>$50K 69 NO ESCALATION | 273,930 | BEVINS M | 1 | 1 | MIKE B | 08-029 |  | 10-065 |  | 09-033 | 09-033 | APP | 08-016 | 3451 | 09-012 | 10-001A |  |  |  |  |  |  |  |  |
| 13451063e-4 |  | PROC 4m Dipl Cntr PP3e-4 Deliver 10 Magnets (ARC10/H-D Dipl) |  | 371d | 2009-06-30 | 2010-12-30 | 13451060M FS+117d | 180d | 0d | PROCUREMENT<$50K 60 NO ESCALATION; PROCUREMENT>$50K 69 NO ESCALATION | 273,930 | BEVINS M | 1 | 1 | MIKE B | 08-029 |  | 10-065 |  | 09-033 | 09-033 | APP | 08-016 | 3451 | 09-012 | 10-001A |  |  |  |  |  |  |  |  |
| 13451066 |  | FY 10 LABOR Oversight 4m Dipl Contract (ARC10/H-D Dipl) |  | 227d | 2009-10-01 | 2010-08-31 | 13451065 | 259d | 79d | MECH ENG [181.52 h]; MECH DES [54.9 h] | 14,436.7 | BEVINS M | 1 | 1 | MIKE B | 08-029 |  | 10-065 |  | 09-033 | 09-033 | APP | 08-016 | 3451 | 09-012 |  |  |  |  |  |  |  |  |  |
| 13451085b |  | P-1 Vend Fab 2m Pass 6 Dipole (ARC10/H-D Dipl) Labor FY10 |  | 182d | 2009-10-01 | 2010-06-28 | 13451085 | 270d | 0d | MECH DES [32.29 h]; MECH ENG [76.32 h] | 6,486.47 | BEVINS M | 1 | 1 | MIKE B |  |  | 10-065 |  |  |  |  |  |  |  | 10-001B |  |  |  |  |  |  |  |  |
| 13451910LOE |  | FY10 Mngmnt & Oversight (ARC10/H-D Dipl) |  | 248d | 2009-10-01 | 2010-09-30 | 13451909LOE, 121451909LOE | 20d | 0d | TRAVEL; SR STAFF [200 h] | 34,035.83 | BEVINS M | 1 | 1 | MIKE B |  |  |  |  |  |  |  |  |  |  |  |  |  |  |  |  |  |  |  |
| 13451068M |  | Deliver 1st Article 4m Dipl (ARC10/H-D Dipl) (IPL 534213030, 534213090 and 534213150) | milestone | 0d | 2009-12-31 | 2009-12-31 | 13451063d, 13451063c, 13451063b, 13451063a | 427d | 247d |  |  | BEVINS M | 1 | 1 | MIKE B | 08-029 |  | 10-065 | 6 | 09-033 | 09-033 | APP |  | 3451 |  |  | IPL |  |  |  |  |  |  |  |
| 13451086 |  | P-2 Vend Fab 2m Pass 6 Dipole (ARC10/H-D Dipl) Original Labor FY10 |  | 171d | 2010-01-29 | 2010-09-30 | 13451085b FS-105d | 270d | 0d | MECH DES [30.34 h]; MECH ENG [68.95 h] | 5,912.94 | BEVINS M | 1 | 1 | MIKE B | 08-029 |  | 10-065 |  |  |  |  | 08-016 |  | 09-012 |  |  | 10-003 | 11-001 |  |  |  |  |  |
| 13451100 |  | Mag Measurement of Arc 10 & H-D Dipl (ARC10/H-D Dipl) (IPL) FY10 |  | 156d | 2010-02-22 | 2010-09-30 | 121421022, 13451090M FS-404d, 13451070M FS-295d | 99d | 0d | MECH TECH [320 h]; MECH ENG [192 h]; COMP SCIENT [8 h]; OFFICE [8 h] | 26,707.44 | BEVINS M | 1 | 1 | MIKE B | 08-029 |  | 10-065 |  |  |  |  |  |  |  |  |  | 10-003 | 11-001 | 10-030 |  |  |  |  |
| 13451086a |  | P-2 Vend Fab 2m Pass 6 Dipole (ARC10/H-D Dipl) Original Labor FY11 |  | 77d | 2010-10-01 | 2011-01-28 | 13451086 | 270d | 171d | MECH ENG [31.05 h]; MECH DES [13.66 h] | 2,747.5 | BEVINS M | 1 | 1 | MIKE B | 08-029 |  | 10-065 |  |  |  |  | 08-016 |  | 09-012 |  |  | 10-003 | 11-001 |  |  |  |  |  |
| 13451100a |  | Mag Measurement of Arc 10 & H-D Dipl (ARC10/H-D Dipl) (IPL) FY11 |  | 234d | 2010-10-01 | 2011-09-12 | 13451100 | 99d | 0d | OFFICE [12 h]; MECH TECH [480 h]; MECH ENG [288 h]; COMP SCIENT [12 h] | 41,338.32 | BEVINS M | 1 | 1 | MIKE B | 08-029 |  | 10-065 |  |  |  |  |  |  |  |  |  | 10-003 | 11-001 | 10-030 |  |  |  |  |
| 13451911LOE |  | FY11 Mngmnt & Oversight (ARC10/H-D Dipl) |  | 248d | 2010-10-01 | 2011-09-30 | 13451910LOE | 20d | 0d | SR STAFF [200 h] | 21,902 | BEVINS M | 1 | 1 | MIKE B |  |  |  |  |  |  |  |  |  |  |  |  |  |  |  |  |  |  |  |
| 13451070M |  | Delivery Complete for all 4m Dipl (ARC10/H-D Dipl) | milestone | 0d | 2010-12-30 | 2010-12-30 | 13451063e-4, 13451068M, 13451063e-3, 13451063e-1, 13451063e-2, 13451066 | 180d | 81d |  |  | BEVINS M | 1 | 1 | MIKE B | 08-029 |  | 10-065 | 6 | 09-033 | 09-033 | APP |  | 3451 |  |  |  |  |  |  |  |  |  |  |
| 13451095 |  | Modify Alignment Fixture for Dipl (ARC10/H-D Dipl) |  | 66d | 2011-04-01 | 2011-07-05 | 9-110M FS+120d | 212d |  | PROCUREMENT<$50K 60; MECH TECH [8 h] | 12,321.32 | BEVINS M | 1 | 1 | MIKE B | 08-029 |  |  |  |  |  |  |  |  |  |  |  |  |  |  | C |  |  |  |
| 13451105 |  | Completion of Mag Measurement of Arc 10 & H-D Dipl (ARC10/H-D Dipl) FY11 |  | 14d | 2011-09-13 | 2011-09-30 | 13451100a | 99d | 0d | MECH TECH [430.77 h]; MECH ENG [163.69 h] | 29,676 | BEVINS M | 1 | 1 | MIKE B |  |  | 10-065 |  |  |  |  |  |  |  |  |  |  |  |  |  | 12-001 |  |  |
| 13451090M |  | Delivery Complete for 2m Pass 6 Dipole (ARC10/H-D Dipl) | milestone | 0d | 2011-09-30 | 2011-09-30 | 13411105v, 13411105x, 13451086a | 99d | 0d |  |  | BEVINS M | 1 | 1 | MIKE B | 08-029 |  | 10-065 | 6 |  |  |  |  |  |  |  |  | 10-003 |  |  |  |  |  |  |
| 13451105a |  | Completion of Mag Measurement of Arc 10 & H-D Dipl (ARC10/H-D Dipl) FY12 |  | 51d | 2011-10-03 | 2011-12-14 | 13451105 | 99d |  | MECH ENG [596.31 h]; MECH TECH [1569.23 h] | 111,549.84 | BEVINS M | 1 | 1 | MIKE B |  |  | 10-065 |  |  |  |  |  |  |  |  |  |  |  |  |  | 12-001 |  |  |
| 13451912LOE |  | FY12 Mngmnt & Oversight (ARC10/H-D Dipl) |  | 247d | 2011-10-03 | 2012-09-28 | 13451911LOE | 20d | 0d | SR STAFF [200 h] | 22,600 | BEVINS M | 1 | 1 | MIKE B |  |  |  |  |  |  |  |  |  |  |  |  |  |  |  |  |  |  |  |
| 13451950 |  | Re-Baseline Actuals Adjustment |  | 1d | 2013-08-30 | 2013-08-30 | 9-130M FS+227d | 20d |  | PROCUREMENT>$50K 69 NO ESCALATION | 206,225.01 | BEVINS M | 1 | 1 | MIKE B |  |  |  |  |  |  |  |  |  |  |  |  |  |  |  |  |  | 13-014 | ADJ |

Notes:
- 13451068M: Explanation: IPL from 6 GeV 534213030, 534213090 / and 534213150

| ID | WBS | Activity | Type | Duration | Start | Finish | Predecessors | Total float | Free float | Resources | Cost | RESP - Responsibility | STRT%COMP for CM EVM | FNSH%COMP for CM EVM | CAM RESPONSIBLE | CR 08-029 | CR 08-058 | Advance Purchase Plan > 500K | CR 08-016 | CR 08-051 | 12 GEV MAJOR PROCUREMENT CATAGORY | CR 09-012 | CR 09-040 | CR 11-026 | CR 12-018 | CR 10-001 | Milestone Level | Inter Project Link (IPL) | CR 08-052 | CR 11-001 | CR 10-030 | CR 10-065 | CR 13-014 | ReBaseline Actuals Adjustment |
| --- | --- | --- | --- | --- | --- | --- | --- | --- | --- | --- | --- | --- | --- | --- | --- | --- | --- | --- | --- | --- | --- | --- | --- | --- | --- | --- | --- | --- | --- | --- | --- | --- | --- | --- |
|  | 2 | **1.3.4.5.2 QUADRUPOLES** |  |  | 2009-01-02 | 2013-08-30 |  |  |  |  |  |  |  |  |  |  |  |  |  |  |  |  |  |  |  |  |  |  |  |  |  |  |  |  |
| 13452025 |  | Prcrmnt Prep for Quads (ARC 10/H-D Q-POLES) |  | 32d | 2009-01-02 | 2009-02-18 | 13452025X | 92d | 115d | MECH DES [28.13 h]; MECH ENG [28.13 h] | 3,028.2 | BEVINS M | 1 | 1 | MIKE B | 08-029 | 08-058 |  |  |  |  |  |  |  |  |  |  |  |  |  |  |  |  |  |
| 13452035 |  | Vend Fab Quads (ARC 10/H-D Q-POLES) LABOR Initial |  | 115d | 2009-02-19 | 2009-07-31 | 9-090M FS+91d | 404d | 0d | MECH DES [74.2 h]; MECH ENG [64.92 h] | 7,395.53 | BEVINS M | 1 | 1 | MIKE B | 08-029 |  | APP | 08-016 | 08-051 | 3422 | 09-012 | 09-040 | 11-026 | 12-018F |  |  |  |  |  |  |  |  |  |
| 13453010 |  | Prcrmnt Prep for Correctors (ARC10/H-D Correctors) FY09 |  | 63d | 2009-07-02 | 2009-09-30 | 9-090M FS+185d | 148d | 0d | MECH ENG [21.72 h]; MECH DES [21.72 h] | 2,338.15 | BEVINS M | 1 | 1 | MIKE B | 08-029 |  |  |  |  |  | 09-012 |  | 11-026 | 12-018F | 10-001B |  |  |  |  |  |  |  |  |
| 13452030M |  | Award Contract for Quadrupoles (ARC 10/H-D Q-POLES) | milestone | 0d | 2009-08-03 | 2009-08-03 | 13452025, 9-090M FS+206d, 1114010 | -23d | 0d |  |  | BEVINS M | 1 | 1 | MIKE B | 08-029 |  |  |  |  |  |  | 09-040 |  |  |  | 6 |  |  |  |  |  |  |  |
| 13452036 |  | Vend Fab Quads (ARC 10/H-D Q-POLES) LABOR Final FY09 |  | 42d | 2009-08-03 | 2009-09-30 | 13452035 | 454d | 0d | MECH DES [25.79 h]; MECH ENG [32.23 h] | 3,187.23 | BEVINS M | 1 | 1 | MIKE B | 08-029 |  | APP | 08-016 |  | 3422 | 09-012 | 09-040 | 11-026 | 12-018F | 10-001B |  |  |  |  |  |  |  |  |
| 13452037 |  | Vend Fab Quads (ARC 10/H-D Q-POLES) Recieve Materials |  | 45d | 2009-08-03 | 2009-10-05 | 13452035 | 652d | 198d | PROCUREMENT<$50K 60 NO ESCALATION; PROCUREMENT>$50K 69 NO ESCALATION | 80,850 | BEVINS M | 1 | 1 | MIKE B | 08-029 |  | APP | 08-016 |  | 3422 | 09-012 | 09-040 | 11-026 | 12-018F | 10-001A |  |  |  |  |  |  |  |  |
| 13452037A |  | Vend Fab Quads (ARC 10/H-D Q-POLES) Lamination Stampings |  | 1d | 2009-08-03 | 2009-08-03 | 13452035 | 696d | 242d | PROCUREMENT>$50K 69 | 18,375 | BEVINS M | 1 | 1 | MIKE B | 08-029 |  | APP | 08-016 |  | 3422 | 09-012 | 09-040 | 11-026 | 12-018F |  |  |  |  |  |  |  |  |  |
| 13452037B |  | Vend Fab Quads (ARC 10/H-D Q-POLES) First Article QP |  | 54d | 2009-08-03 | 2009-10-16 | 13452035 | 404d | 0d | PROCUREMENT>$50K 69 NO ESCALATION | 19,500 | BEVINS M | 1 | 1 | MIKE B | 08-029 |  | APP | 08-016 |  | 3422 | 09-012 | 09-040 | 11-026 | 12-018F | 10-001A |  |  |  |  |  |  |  |  |
| 13452037C |  | Vend Fab Quads (ARC 10/H-D Q-POLES) Deliver 8 QP Magnets |  | 101d | 2009-08-03 | 2009-12-31 | 13452035 | 596d | 142d | PROCUREMENT>$50K 69 NO ESCALATION | 56,000 | BEVINS M | 1 | 1 | MIKE B | 08-029 |  | APP | 08-016 |  | 3422 | 09-012 | 09-040 | 11-026 | 12-018F | 10-001A |  |  |  |  |  |  |  |  |
| 13452037D |  | Vend Fab Quads (ARC 10/H-D Q-POLES) Deliver 8 QP Magnets |  | 120d | 2009-08-03 | 2010-01-29 | 13452035 | 577d | 123d | PROCUREMENT>$50K 69 NO ESCALATION | 56,000 | BEVINS M | 1 | 1 | MIKE B | 08-029 |  | APP | 08-016 |  | 3422 | 09-012 | 09-040 | 11-026 | 12-018F | 10-001A |  |  |  |  |  |  |  |  |
| 13452037F |  | Vend Fab Quads (ARC 10/H-D Q-POLES) Deliver 3 QR Magnets |  | 120d | 2009-08-03 | 2010-01-29 | 13452035 | 577d | 123d | PROCUREMENT>$50K 69 NO ESCALATION | 23,100 | BEVINS M | 1 | 1 | MIKE B | 08-029 |  | APP | 08-016 |  | 3422 | 09-012 | 09-040 | 11-026 | 12-018F | 10-001A |  |  |  |  |  |  |  |  |
| 13452037G |  | Vend Fab Quads (ARC 10/H-D Q-POLES) Deliver 8 QP Magnets |  | 139d | 2009-08-03 | 2010-02-26 | 13452035 | 558d | 104d | PROCUREMENT>$50K 69 NO ESCALATION | 56,000 | BEVINS M | 1 | 1 | MIKE B | 08-029 |  | APP | 08-016 |  | 3422 | 09-012 | 09-040 | 11-026 | 12-018F | 10-001A |  |  |  |  |  |  |  |  |
| 13452037H |  | Vend Fab Quads (ARC 10/H-D Q-POLES) Deliver 3 QR Magnets |  | 139d | 2009-08-03 | 2010-02-26 | 13452035 | 558d | 104d | PROCUREMENT>$50K 69 NO ESCALATION | 23,100 | BEVINS M | 1 | 1 | MIKE B | 08-029 |  | APP | 08-016 |  | 3422 | 09-012 | 09-040 | 11-026 | 12-018F | 10-001A |  |  |  |  |  |  |  |  |
| 13452037J |  | Vend Fab Quads (ARC 10/H-D Q-POLES) Deliver 8 QP Magnets |  | 160d | 2009-08-03 | 2010-03-29 | 13452035 | 537d | 83d | PROCUREMENT>$50K 69 NO ESCALATION | 56,000 | BEVINS M | 1 | 1 | MIKE B | 08-029 |  | APP | 08-016 |  | 3422 | 09-012 | 09-040 | 11-026 | 12-018F | 10-001A |  |  |  |  |  |  |  |  |
| 13452037K |  | Vend Fab Quads (ARC 10/H-D Q-POLES) Deliver 3 QR Magnets |  | 160d | 2009-08-03 | 2010-03-29 | 13452035 | 537d | 83d | PROCUREMENT>$50K 69 NO ESCALATION | 23,100 | BEVINS M | 1 | 1 | MIKE B | 08-029 |  | APP | 08-016 |  | 3422 | 09-012 | 09-040 | 11-026 | 12-018F | 10-001A |  |  |  |  |  |  |  |  |
| 13452037L |  | Vend Fab Quads (ARC 10/H-D Q-POLES) Deliver 8 QP Magnets |  | 184d | 2009-08-03 | 2010-04-30 | 13452035 | 513d | 59d | PROCUREMENT>$50K 69 NO ESCALATION | 56,000 | BEVINS M | 1 | 1 | MIKE B | 08-029 |  | APP | 08-016 |  | 3422 | 09-012 | 09-040 | 11-026 | 12-018F | 10-001A |  |  |  |  |  |  |  |  |
| 13452037N |  | Vend Fab Quads (ARC 10/H-D Q-POLES) Deliver 3 QR Magnets |  | 184d | 2009-08-03 | 2010-04-30 | 13452035 | 513d | 59d | PROCUREMENT>$50K 69 NO ESCALATION | 23,100 | BEVINS M | 1 | 1 | MIKE B | 08-029 |  | APP | 08-016 |  | 3422 | 09-012 | 09-040 | 11-026 | 12-018F | 10-001A |  |  |  |  |  |  |  |  |
| 13452037P |  | Vend Fab Quads (ARC 10/H-D Q-POLES) Deliver 3 QR Magnets |  | 204d | 2009-08-03 | 2010-05-28 | 13452035 | 493d | 39d | PROCUREMENT>$50K 69 NO ESCALATION | 23,100 | BEVINS M | 1 | 1 | MIKE B | 08-029 |  | APP | 08-016 |  | 3422 | 09-012 | 09-040 | 11-026 | 12-018F | 10-001A |  |  |  |  |  |  |  |  |
| 13452037Q |  | Vend Fab Quads (ARC 10/H-D Q-POLES) Deliver 4 QP Magnets |  | 221d | 2009-08-03 | 2010-06-23 | 13452035 | 476d | 22d | PROCUREMENT>$50K 69 NO ESCALATION | 28,000 | BEVINS M | 1 | 1 | MIKE B | 08-029 |  | APP | 08-016 |  | 3422 | 09-012 | 09-040 | 11-026 | 12-018F | 10-001A |  |  |  |  |  |  |  |  |
| 13452037R |  | Vend Fab Quads (ARC 10/H-D Q-POLES) Deliver 3 QR Magnets |  | 221d | 2009-08-03 | 2010-06-23 | 13452035 | 476d | 22d | PROCUREMENT>$50K 69 NO ESCALATION | 23,100 | BEVINS M | 1 | 1 | MIKE B | 08-029 |  | APP | 08-016 |  | 3422 | 09-012 | 09-040 | 11-026 | 12-018F | 10-001A |  |  |  |  |  |  |  |  |
| 13452037S |  | Vend Fab Quads (ARC 10/H-D Q-POLES) Deliver 2 QR Magnets |  | 243d | 2009-08-03 | 2010-07-26 | 13452035 | 454d | 0d | PROCUREMENT>$50K 69 NO ESCALATION | 15,400 | BEVINS M | 1 | 1 | MIKE B | 08-029 |  | APP | 08-016 |  | 3422 | 09-012 | 09-040 | 11-026 | 12-018F | 10-001A |  |  |  |  |  |  |  |  |
| 13452037T |  | Vend Fab Quads (ARC 10/H-D Q-POLES) Deliver 4 QP Magnets |  | 240d | 2009-08-03 | 2010-07-21 | 13452035 | 457d | 3d | PROCUREMENT<$50K 60 NO ESCALATION | 38,400 | BEVINS M | 1 | 1 | MIKE B | 08-029 |  | APP | 08-016 |  | 3422 | 09-012 | 09-040 | 11-026 | 12-018F | 10-001A |  |  |  |  |  |  |  |  |
| 13452037o |  | Vend Fab Quads (ARC 10/H-D Q-POLES) Deliver 8 QP Magnets |  | 204d | 2009-08-03 | 2010-05-28 | 13452035 | 493d | 39d | PROCUREMENT>$50K 69 NO ESCALATION | 56,000 | BEVINS M | 1 | 1 | MIKE B | 08-029 |  | APP | 08-016 |  | 3422 | 09-012 | 09-040 | 11-026 | 12-018F | 10-001A |  |  |  |  |  |  |  |  |
| 13452036b |  | Vend Fab Quads (ARC 10/H-D Q-POLES) LABOR Final FY10 |  | 201d | 2009-10-01 | 2010-07-26 | 13452036 | 454d | 0d | MECH DES [123.4 h]; MECH ENG [154.26 h] | 15,740.64 | BEVINS M | 1 | 1 | MIKE B |  |  | APP |  |  | 3422 |  |  | 11-026 | 12-018F | 10-001B |  |  |  |  |  |  |  |  |
| 13453010b |  | Prcrmnt Prep for Correctors (ARC10/H-D Correctors) FY10 |  | 53d | 2009-10-01 | 2009-12-16 | 13453010 | 148d | 0d | MECH ENG [18.28 h]; MECH DES [18.28 h] | 2,030.73 | BEVINS M | 1 | 1 | MIKE B |  |  |  |  |  |  |  |  | 11-026 | 12-018F | 10-001B |  |  |  |  |  |  |  |  |
| 13452038M |  | Deliver 1st Article Quadrupoles (ARC 10/H-D Q-POLES) (IPL 534213165) | milestone | 0d | 2009-10-16 | 2009-10-16 | 13452037B, 13452030M | 404d | 0d |  |  | BEVINS M | 1 | 1 | MIKE B | 08-029 |  |  |  |  |  |  | 09-040 | 11-026 | 12-018F |  | 6 | IPL |  |  |  |  |  |  |
| 13453015M |  | Award Contract for Correctors (ARC10/H-D CORRECTORS) | milestone | 0d | 2009-12-16 | 2009-12-16 | 9-100M, 13453010b | 148d | 0d |  |  | BEVINS M | 1 | 1 | MIKE B |  |  |  |  |  |  |  |  | 11-026 | 12-018F |  | 6 |  | 08-052 |  |  |  |  |  |
| 13453020 |  | Vend Fab Correctors (ARC10/H-D Correctors) Labor FY10 |  | 195d | 2009-12-17 | 2010-09-30 | 13453015M | 148d | 0d | MECH DES [59.77 h]; MECH ENG [89.66 h] | 8,608.1 | BEVINS M | 1 | 1 | MIKE B | 08-029 |  | APP | 08-016 | 08-051 |  | 09-012 |  | 11-026 | 12-018F |  |  |  |  | 11-001 |  |  |  |  |
| 13453020b |  | Vend Fab Correctors (ARC10/H-D Correctors) Procurement |  | 261d | 2009-12-17 | 2011-01-12 | 13453015M | 148d | 0d | PROCUREMENT>$50K 69 NO ESCALATION FY11; PROCUREMENT<$50K 60 NO ESCALATION FY11 | 178,023.87 | BEVINS M | 1 | 1 | MIKE B | 08-029 |  | APP | 08-016 | 08-051 |  | 09-012 |  | 11-026 | 12-018F |  |  |  |  | 11-001 |  |  |  |  |
| 13452045 |  | Mag Measurment of New Quads (ARC 10/H-D Q-POLES) Labor FY10 |  | 117d | 2010-04-16 | 2010-09-30 | 13452040M FS-120d, 13452038M FS+119d | 404d | 0d | COMP SCIENT [23.4 h]; OFFICE [23.4 h]; MECH ENG [280.8 h]; MECH TECH [468 h] | 40,094.26 | BEVINS M | 1 | 1 | MIKE B | 08-029 |  | APP | 08-016 |  |  | 09-012 | 09-040 | 11-026 | 12-018F |  |  |  |  | 11-001 | 10-030 |  |  |  |
| 13452045b |  | Mag Measurment of New Quads (ARC 10/H-D Q-POLES) Procurement |  | 200d | 2010-04-16 | 2011-02-07 | 13452040M FS-120d, 13452038M FS+119d | 404d | 318d | PROCUREMENT<$50K 60 NO ESCALATION FY11 | 2,637.08 | BEVINS M | 1 | 1 | MIKE B | 08-029 |  | APP | 08-016 |  |  | 09-012 | 09-040 | 11-026 | 12-018F |  |  |  |  | 11-001 | 10-030 |  |  |  |
| 13452050 |  | Completion of Quadrapole Mag Measurement FY10 |  | 64d | 2010-07-01 | 2010-09-30 | 9-100M FS+184d | 254d | 0d | MECH ENG [435.37 h]; MECH TECH [1131.97 h] | 75,917.54 | BEVINS M | 1 | 1 | MIKE B |  |  | APP |  |  |  |  |  | 11-026 | 12-018F |  |  |  |  | 11-001 |  | 10-065 |  |  |
| 13452040M |  | Delivery Complete for Quadrupoles (ARC 10/H-D Q-POLES) | milestone | 0d | 2010-07-26 | 2010-07-26 | 13452037G, 13452037Q, 13452037J, 13452037H, 13452037R, 13452037D, 13452037N, 13452037S, 13452037C, 13452037o, 13452037L, 13452038M, 13452037A, 13452037F, 13452037B, 13452037, 13452037K, 13452037T, 13452036b, 13452037P | 454d | 50d |  |  | BEVINS M | 1 | 1 | MIKE B | 08-029 |  |  |  |  |  |  | 09-040 | 11-026 | 12-018F |  | 6 |  |  |  |  |  |  |  |
| 13452045a |  | Mag Measurment of New Quads (ARC 10/H-D Q-POLES) Labor FY11 |  | 83d | 2010-10-01 | 2011-02-07 | 13452045 | 404d | 318d | COMP SCIENT [16.6 h]; OFFICE [16.6 h]; MECH ENG [199.2 h]; MECH TECH [332 h] | 29,349.79 | BEVINS M | 1 | 1 | MIKE B | 08-029 |  | APP | 08-016 |  |  | 09-012 | 09-040 | 11-026 | 12-018F |  |  |  |  | 11-001 | 10-030 |  |  |  |
| 13452050a |  | Completion of Quadrapole Mag Measurement FY11 |  | 83d | 2010-10-01 | 2011-02-07 | 9-100M FS+184d, 13452050 | 254d | 168d | MECH ENG [564.63 h]; MECH TECH [1468.03 h] | 101,594.66 | BEVINS M | 1 | 1 | MIKE B |  |  | APP |  |  |  |  |  | 11-026 | 12-018F |  |  |  |  | 11-001 |  | 10-065 |  |  |
| 13453020a |  | Vend Fab Correctors (ARC10/H-D Correctors) Labor FY11 |  | 66d | 2010-10-01 | 2011-01-12 | 13453020 | 148d | 0d | MECH DES [20.23 h]; MECH ENG [30.34 h] | 3,005.94 | BEVINS M | 1 | 1 | MIKE B | 08-029 |  | APP | 08-016 | 08-051 |  | 09-012 |  | 11-026 | 12-018F |  |  |  |  | 11-001 |  |  |  |  |
| 13453025 |  | Delivery Complete for Correctors (ARC10/H-D CORRECTORS) | milestone | 0d | 2011-01-12 | 2011-01-12 | 13453020a, 13453020b | 148d | 0d |  |  | BEVINS M | 1 | 1 | MIKE B |  |  |  |  |  |  |  |  | 11-026 | 12-018F |  |  |  | 08-052 |  |  |  |  |  |
| 13453030 |  | Mag Measurment of Correctors (ARC10/H-D Correctors) |  | 123d | 2011-01-13 | 2011-07-08 | 13453015M FS+159d, 13453025 | 148d | 62d | COMP SCIENT [20 h]; OFFICE [20 h]; MECH TECH [184 h]; MECH ENG [12 h] | 10,565.48 | BEVINS M | 1 | 1 | MIKE B | 08-029 |  |  |  |  |  |  |  | 11-026 | 12-018F |  |  |  |  |  | 10-030 |  |  |  |
| 13452055 |  | Re-Baseline Actuals Adjustment |  | 1d | 2013-08-30 | 2013-08-30 | 9-130M FS+227d | 20d |  | PROCUREMENT>$50K 69 NO ESCALATION | -60,765.62 | BEVINS M | 1 | 1 | MIKE B |  |  |  |  |  |  |  |  |  |  |  |  |  |  |  |  |  | 13-014 | ADJ |

Notes:
- 13452038M: Explanation: IPL from 6 GeV 53421365

| ID | WBS | Activity | Type | Duration | Start | Finish | Predecessors | Total float | Free float | Calendar | Resources | Cost | RESP - Responsibility | STRT%COMP for CM EVM | FNSH%COMP for CM EVM | CR 08-016 | CAM RESPONSIBLE | CR 08-029 | CR 09-012 | CR 09-034 | CR 10-030 | CR 10-065 | CR 08-051 | Milestone Level | CR 10-070 | CR 12-035 | Profile change | CR 12-018 | CR 08-059 | CR 11-057 | CR 11-001 | CR 12-015 | CR 11-026 | CR 12-039 | CR 13-014 | ReBaseline Actuals Adjustment | Original Activity ID Rebaseline | Over Under Fixed | EVMS Reporting Codes | BOE Labor | BOE Expenses | CR 13-015 | Post Rebaseline | Obligated Prior to Rebaseline | CR 14-001 |
| --- | --- | --- | --- | --- | --- | --- | --- | --- | --- | --- | --- | --- | --- | --- | --- | --- | --- | --- | --- | --- | --- | --- | --- | --- | --- | --- | --- | --- | --- | --- | --- | --- | --- | --- | --- | --- | --- | --- | --- | --- | --- | --- | --- | --- | --- |
|  | 3 | **1.3.4.5.3 CORRECTORS** |  |  |  |  |  |  |  |  |  |  |  |  |  |  |  |  |  |  |  |  |  |  |  |  |  |  |  |  |  |  |  |  |  |  |  |  |  |  |  |  |  |  |  |
|  | 4 | **1.3.4.5.4 STANDS** |  |  | 2010-01-05 | 2013-10-23 |  |  |  |  |  |  |  |  |  |  |  |  |  |  |  |  |  |  |  |  |  |  |  |  |  |  |  |  |  |  |  |  |  |  |  |  |  |  |  |
| 13455015 |  | Proc/Vend Fab Arc 10 Griders (ARC 10/H-D Girders) (Original) |  | 37d | 2010-01-05 | 2010-02-26 | 121456999, 9-100M FS+60d, 121455015M | 200d | 191d |  | MECH DES [18.5 h]; MECH ENG [8.88 h]; MECH TECH [14.8 h] | 2,039.44 | BEVINS M | 1 | 1 | 08-016 | MIKE B | 08-029 | 09-012 | 09-034 | 10-030 | 10-065 |  |  |  |  |  |  |  |  |  |  |  |  |  |  |  |  |  |  |  |  |  |  |  |
| 13455020 |  | Proc/Vend Fab H-D Girders (ARC 10/H-D Girders) (Original) |  | 37d | 2010-01-05 | 2010-02-26 | 121456999, 121455015M, 9-100M FS+60d | 200d | 191d |  | MECH TECH [11.1 h]; MECH DES [18.5 h]; MECH ENG [8.88 h] | 1,885 | BEVINS M | 1 | 1 | 08-016 | MIKE B | 08-029 | 09-012 | 09-034 | 10-030 | 10-065 | 08-051 |  |  |  |  |  |  |  |  |  |  |  |  |  |  |  |  |  |  |  |  |  |  |
| 13454020M |  | Award Arc 10 Stands | milestone | 0d | 2010-03-15 | 2010-03-15 | 13454015 FS-191d | 716d | 0d |  |  |  | BEVINS M | 1 | 1 |  | MIKE B |  |  |  | 10-030 | 10-065 |  | 6 | 10-070 | 12-035F |  |  |  |  |  |  |  |  |  |  |  |  |  |  |  |  |  |  |  |
| 13454022LOE |  | Vend Fab Arc 10 Stands Oversight |  | 75d | 2010-03-15 | 2010-06-28 | 13454020M | 716d | 246d |  | MECH DES [50 h]; MECH ENG [20 h] | 3,579 | BEVINS M | 1 | 1 |  | MIKE B |  |  |  | 10-030 | 10-065 |  |  | 10-070 | 12-035F |  |  |  |  |  |  |  |  |  |  |  |  |  |  |  |  |  |  |  |
| 13454025 |  | Vend Fab Arc 10 Stands Phase 1 |  | 51d | 2010-03-15 | 2010-05-24 | 13454020M | 716d | 0d |  | PROCUREMENT<$50K 60 | 15,000 | BEVINS M | 1 | 1 |  | MIKE B | 08-029 |  |  | 10-030 | 10-065 | 08-051 |  | 10-070 | 12-035F |  |  |  |  |  |  |  |  |  |  |  |  |  |  |  |  |  |  |  |
| 13454025A |  | Vend Fab Arc 10 Stands Phase 2 |  | 64d | 2010-03-15 | 2010-06-11 | 13454025 FS-51d | 716d | 0d |  | PROCUREMENT<$50K 60 | 15,000 | BEVINS M | 1 | 1 |  | MIKE B |  |  |  | 10-030 | 10-065 |  |  | 10-070 | 12-035F |  |  |  |  |  |  |  |  |  |  |  |  |  |  |  |  |  |  |  |
| 13454025B |  | Vend Fab Arc 10 Stands Phase 3 |  | 75d | 2010-03-15 | 2010-06-28 | 13454025A FS-64d | 716d | 0d |  | PROCUREMENT<$50K 60 | 15,000 | BEVINS M | 1 | 1 |  | MIKE B |  |  |  | 10-030 | 10-065 |  |  | 10-070 | 12-035F |  |  |  |  |  |  |  |  |  |  |  |  |  |  |  |  |  |  |  |
| 13454031 |  | Prcrmnt Prep for Hall D Girder Floor Plates |  | 20d | 2010-04-01 | 2010-04-28 | 9-100M FS+120d | 869d | 0d |  | MECH ENG [12 h] | 790.2 | BEVINS M | 1 | 1 |  | MIKE B |  |  |  | 10-030 | 10-065 |  |  | 10-070 | 12-035F | C | 12-018F |  |  |  |  |  |  |  |  |  |  |  |  |  |  |  |  |  |
| 13455010 |  | Proc Prep For Arc 10 Girders |  | 73d | 2010-04-05 | 2010-07-16 | 9-100M FS+122d | 12d | 0d |  | MECH ENG [240 h]; MECH TECH [160 h]; MECH DES [120 h] | 27,911.2 | BEVINS M | 1 | 1 |  | MIKE B | 08-029 |  | 09-034 | 10-030 | 10-065 |  |  |  |  |  |  | 08-059 |  |  |  |  |  |  |  |  |  |  |  |  |  |  |  |  |
| 13454032 |  | Vend fab Hall D Girder Floor Plates |  | 39d | 2010-04-29 | 2010-06-23 | 13454031 | 869d | 642d |  | PROCUREMENT<$50K 60 | 4,100 | BEVINS M | 1 | 1 |  | MIKE B |  |  |  | 10-030 | 10-065 |  |  | 10-070 | 12-035F | C | 12-018F |  |  |  |  |  |  |  |  |  |  |  |  |  |  |  |  |  |
| 13454026 |  | Receive and Inspect Arc 10 Stands |  | 24d | 2010-05-25 | 2010-06-28 | 13454025, 13454025B FS-24d | 716d | 0d |  | MECH ENG [20 h]; MECH TECH [70 h] | 4,238.8 | BEVINS M | 1 | 1 |  | MIKE B |  |  |  | 10-030 | 10-065 |  |  | 10-070 | 12-035F |  |  |  |  |  |  |  |  |  |  |  |  |  |  |  |  |  |  |  |
| 13455075 |  | Prcrmnt Prep for Hall D Stands Phase 1 |  | 22d | 2010-06-01 | 2010-06-30 | 9-100M FS+162d | 624d | 232d |  | MECH ENG [40 h]; MECH DES [20 h] | 3,538.8 | BEVINS M | 1 | 1 |  | MIKE B |  |  |  | 10-030 | 10-065 |  |  | 10-070 | 12-035F | C | 12-018F |  | 11-057 |  |  |  |  |  |  |  |  |  |  |  |  |  |  |  |
| 13455115 |  | Proc Prep Arc 10 Floor to Ceiling Stands |  | 56d | 2010-06-04 | 2010-08-23 | 9-100M FS+165d | 551d | 0d |  | MECH DES [40 h]; MECH ENG [160 h] | 12,345.6 | BEVINS M | 1 | 1 |  | MIKE B |  |  |  | 10-030 | 10-065 |  |  | 10-070 | 12-035F |  |  |  |  |  |  |  |  |  |  |  |  |  |  |  |  |  |  |  |
| 13454030M |  | Delivery Complete for Arc 10 Stands | milestone | 0d | 2010-06-28 | 2010-06-28 | 13454026 | 716d | 218d |  |  |  | BEVINS M | 1 | 1 |  | MIKE B |  |  |  | 10-030 | 10-065 |  | 6 | 10-070 | 12-035F |  |  |  |  |  |  |  |  |  |  |  |  |  |  |  |  |  |  |  |
| 13455023 |  | Vend Fab Arc 10 Girders Oversight FY10 |  | 53d | 2010-07-19 | 2010-09-30 | 13455010 | 13d | 0d |  | MECH ENG [23.82 h]; MECH DES [35.73 h] | 3,184.98 | BEVINS M | 1 | 1 |  | MIKE B |  |  |  | 10-030 | 10-065 |  |  |  |  |  |  |  |  | 11-001 |  |  |  |  |  |  |  |  |  |  |  |  |  |  |
| 13455025 |  | Vend Fab Arc 10 Girders Phase 1 |  | 69d | 2010-07-19 | 2010-10-22 | 13455010 | 12d | 0d |  | PROCUREMENT<$50K 60 NO ESCALATION FY11; PROCUREMENT>$50K 69 NO ESCALATION FY11 | 92,188 | BEVINS M | 1 | 1 |  | MIKE B |  |  |  | 10-030 | 10-065 |  |  |  |  |  |  |  |  |  |  |  |  |  |  |  |  |  |  |  |  |  |  |  |
| 13455028 |  | Vend Fab Arc 10 Girders Phase 2 |  | 100d | 2010-07-19 | 2010-12-08 | 13455025 FS-69d | 12d | 0d |  | PROCUREMENT>$50K 69 NO ESCALATION FY11 | 92,188 | BEVINS M | 1 | 1 |  | MIKE B |  |  |  | 10-030 | 10-065 |  |  |  |  |  |  |  |  |  |  |  |  |  |  |  |  |  |  |  |  |  |  |  |
| 13454042 |  | Prcrmnt Prep for Alignment Cartridges (ARC10/H-D Stands) FY10 |  | 43d | 2010-08-02 | 2010-09-30 | 9-100M FS+205d | 272d | 0d |  | MECH DES [4.35 h]; MECH ENG [43.54 h] | 3,063.9 | BEVINS M | 1 | 1 |  | MIKE B |  |  |  | 10-030 |  |  |  |  |  | C |  |  |  | 11-001 |  |  |  |  |  |  |  |  |  |  |  |  |  |  |
| 13455130 |  | Proc Prep Tagger Dump Enclosure |  | 39d | 2010-08-02 | 2010-09-24 | 9-100M FS+205d | 1286d | 0d |  | MECH DES [160 h]; MECH ENG [80 h] | 12,506.4 | BEVINS M | 1 | 1 |  | MIKE B |  |  |  |  | 10-065 |  |  |  |  |  |  |  |  |  | 12-015 |  |  |  |  |  |  |  |  |  |  |  |  |  |
| 13455140 |  | Proc Prep Hall D Movaable Shield Wall FY10 |  | 43d | 2010-08-02 | 2010-09-30 | 9-100M FS+205d | 1179d | 0d |  | MECH ENG [103.2 h]; MECH DES [206.4 h] | 16,133.26 | BEVINS M | 1 | 1 |  | MIKE B |  |  |  |  | 10-065 |  |  |  |  |  |  |  |  | 11-001 | 12-015 |  |  |  |  |  |  |  |  |  |  |  |  |  |
| 13455035 |  | Vend Fab Hall D Floor Girders |  | 77d | 2010-08-09 | 2010-11-24 | 9-100M FS+210d | 10d | 1d |  | PROCUREMENT>$50K 69 NO ESCALATION FY11 | 34,000 | BEVINS M | 1 | 1 |  | MIKE B |  |  |  | 10-030 | 10-065 |  |  |  |  |  |  |  |  |  |  |  |  |  |  |  |  |  |  |  |  |  |  |  |
| 13455135 |  | Vend Fab Tagger Dump Enclosure |  | 39d | 2010-08-20 | 2010-10-14 | 13455130 FS-25d | 1286d | 279d |  | PROCUREMENT<$50K 60 NO ESCALATION FY11 | 12,000 | BEVINS M | 1 | 1 |  | MIKE B |  |  |  |  | 10-065 |  |  |  |  |  |  |  |  |  | 12-015 |  |  |  |  |  |  |  |  |  |  |  |  |  |
| 13454015 |  | Prcrmnt Prep for Arc 10 Stands |  | 50d | 2010-10-01 | 2010-12-13 | 121456999, 9-110M, 121454015a | 716d | 0d |  | MECH DES [40 h]; MECH ENG [140 h] | 11,380.2 | BEVINS M | 1 | 1 |  | MIKE B | 08-029 |  |  | 10-030 | 10-065 |  |  | 10-070 | 12-035F | C |  |  |  |  |  |  |  |  |  |  |  |  |  |  |  |  |  |  |
| 13454035 |  | Proc Misc Brackets & Hardware (ARC10/H-D Stands) |  | 130d | 2010-10-01 | 2011-04-14 | 121456999, 9-110M | 520d | 22d |  | MECH DES [120 h]; PROCUREMENT<$50K 60; MECH ENG [100 h] | 21,467.29 | BEVINS M | 1 | 1 |  | MIKE B |  |  |  | 10-030 | 10-065 |  |  | 10-070 | 12-035F |  |  |  |  |  |  |  |  |  |  |  |  |  |  |  |  |  |  |  |
| 13454042a |  | Prcrmnt Prep for Alignment Cartridges (ARC10/H-D Stands) FY11 |  | 36d | 2010-10-01 | 2010-11-19 | 13454042 | 272d | 0d |  | MECH DES [3.65 h]; MECH ENG [36.46 h] | 2,647.84 | BEVINS M | 1 | 1 |  | MIKE B |  |  |  | 10-030 |  |  |  |  |  | C |  |  |  | 11-001 |  |  |  |  |  |  |  |  |  |  |  |  |  |  |
| 13455023a |  | Vend Fab Arc 10 Girders Oversight FY11 |  | 36d | 2010-10-01 | 2010-11-19 | 13455023 | 13d | 4d |  | MECH DES [24.27 h]; MECH ENG [16.18 h] | 2,232.35 | BEVINS M | 1 | 1 |  | MIKE B |  |  |  | 10-030 | 10-065 |  |  |  |  |  |  |  |  | 11-001 |  |  |  |  |  |  |  |  |  |  |  |  |  |  |
| 13455140a |  | Proc Prep Hall D Movaable Shield Wall FY11 |  | 7d | 2010-10-01 | 2010-10-11 | 13455140 | 1179d | 0d |  | MECH DES [33.6 h]; MECH ENG [16.8 h] | 2,710.01 | BEVINS M | 1 | 1 |  | MIKE B |  |  |  |  | 10-065 |  |  |  |  |  |  |  |  | 11-001 | 12-015 |  |  |  |  |  |  |  |  |  |  |  |  |  |
| 13455145 |  | Vend Fab Hall D Movaable Shield Wall |  | 110d | 2010-10-12 | 2011-03-28 | 13455140a | 1179d | 172d |  | PROCUREMENT<$50K 60 | 41,276 | BEVINS M | 1 | 1 |  | MIKE B |  |  |  |  | 10-065 |  |  |  |  |  |  |  |  |  | 12-015 |  |  |  |  |  |  |  |  |  |  |  |  |  |
| 13455030 |  | Receive and Inspect Arc 10 Girders |  | 20d | 2010-11-09 | 2010-12-08 | 13455025, 13455028 FS-20d | 12d | 3d |  | MECH ENG [8 h]; MECH TECH [80 h] | 3,989.2 | BEVINS M | 1 | 1 |  | MIKE B |  |  |  | 10-030 | 10-065 |  |  |  |  |  |  |  |  |  |  |  |  |  |  |  |  |  |  |  |  |  |  |  |
| 13455120 |  | Vend Fab Arc 10 Floor to Ceiling Stands |  | 67d | 2010-11-17 | 2011-03-03 | 13455115 FS+60d | 551d | 0d |  | PROCUREMENT<$50K 60 | 15,478.5 | BEVINS M | 1 | 1 |  | MIKE B |  |  |  | 10-030 | 10-065 |  |  | 10-070 | 12-035F |  |  |  |  |  |  |  |  |  |  |  |  |  |  |  |  |  |  |  |
| 13454045 |  | Vend Fab Alignment Cartridges (ARC10/H-D Stands) |  | 90d | 2010-11-22 | 2011-04-08 | 13454042a | 272d | 0d |  | PROCUREMENT<$50K 60 | 61,737.79 | BEVINS M | 1 | 1 |  | MIKE B | 08-029 | 09-012 |  | 10-030 |  | 08-051 |  |  |  | C |  |  |  |  |  |  |  |  |  |  |  |  |  |  |  |  |  |  |
| 13455040 |  | Proc Prep For Hall D Girders |  | 82d | 2010-12-03 | 2011-04-07 | 9-110M FS+43d | 109d | 0d |  | MECH DES [40 h]; MECH ENG [80 h] | 7,303.2 | BEVINS M | 1 | 1 |  | MIKE B |  |  |  | 10-030 |  |  |  |  |  |  | 12-018F |  |  |  |  | 11-026 |  |  |  |  |  |  |  |  |  |  |  |  |
| 13454036 |  | Prcrmnt Prep for Insertable Dumps (ARC10/H-D Stands) |  | 42d | 2011-01-05 | 2011-03-07 | 9-110M FS+60d | 229d | 212d |  | MECH ENG [120 h]; MECH DES [16 h] | 8,900.88 | BEVINS M | 1 | 1 |  | MIKE B |  |  |  | 10-030 |  |  |  |  |  | C |  |  | 11-057 |  |  |  |  |  |  |  |  |  |  |  |  |  |  |  |
| 13455125 |  | Receive and Inspect Arc 10 Floor to Ceiling Stands |  | 10d | 2011-02-17 | 2011-03-03 | 13455120 FS-10d | 551d | 52d |  | MECH ENG [40 h]; MECH TECH [80 h] | 6,163.6 | BEVINS M | 1 | 1 |  | MIKE B |  |  |  | 10-030 | 10-065 |  |  | 10-070 | 12-035F |  |  |  |  |  |  |  |  |  |  |  |  |  |  |  |  |  |  |  |
| 13454047 |  | Receive and Inspect Alignment Cartridges (ARC10/H-D Stands) |  | 10d | 2011-03-28 | 2011-04-08 | 13454045 FS-10d | 272d |  |  | MECH TECH [20 h] | 861.4 | BEVINS M | 1 | 1 |  | MIKE B |  |  |  | 10-030 |  |  |  |  |  | C |  |  |  |  |  |  |  |  |  |  |  |  |  |  |  |  |  |  |
| 13455045 |  | Vend Fab Hall D Girders Oversight |  | 103d | 2011-04-08 | 2011-09-01 | 13455040 | 109d | 23d |  | MECH DES [60 h]; MECH ENG [40 h] | 5,518.8 | BEVINS M | 1 | 1 |  | MIKE B |  |  |  | 10-030 |  |  |  |  |  |  | 12-018F |  |  |  |  | 11-026 |  |  |  |  |  |  |  |  |  |  |  |  |
| 13455050 |  | Vend Fab Hall D Girders Part 1 |  | 78d | 2011-04-08 | 2011-07-28 | 13455040 | 109d | 0d |  | PROCUREMENT<$50K 60 | 30,052.02 | BEVINS M | 1 | 1 |  | MIKE B |  |  |  | 10-030 |  |  |  |  |  |  | 12-018F |  |  |  |  | 11-026 |  |  |  |  |  |  |  |  |  |  |  |  |
| 13455055 |  | Vend Fab Hall D Girders Part 2 |  | 103d | 2011-04-08 | 2011-09-01 | 13455050 FS-78d | 109d | 0d |  | PROCUREMENT<$50K 60; PROCUREMENT>$50K 69 | 30,052.03 | BEVINS M | 1 | 1 |  | MIKE B |  |  |  | 10-030 |  |  |  |  |  |  | 12-018F |  |  |  |  | 11-026 |  |  |  |  |  |  |  |  |  |  |  |  |
| 13454050 |  | 100 kW dump Modifications (ARC10/H-D Stands) Original |  | 37d | 2011-06-08 | 2011-07-29 | 13458030 FS-18d | 549d |  |  | MECH TECH [40 h]; MECH DES [40 h]; MECH ENG [60 h] | 7,667 | BEVINS M | 1 | 1 |  | MIKE B | 08-029 | 09-012 |  | 10-030 |  |  |  |  |  |  |  |  | 11-057 |  |  |  |  |  |  |  |  |  |  |  |  |  |  |  |
| 13455080 |  | Prcrmnt Prep for Hall D Stands Phase 2 |  | 80d | 2011-06-09 | 2011-09-30 | 9-120M FS-80d, 13455075 | 392d | 68d |  | MECH ENG [120 h]; MECH DES [60 h] | 10,954.8 | BEVINS M | 1 | 1 |  | MIKE B |  |  |  |  | 10-065 |  |  |  | 12-035F | C | 12-018F |  | 11-057 |  |  |  |  |  |  |  |  |  |  |  |  |  |  |  |
| 13455060 |  | Receive and Inspect Hall D Girders |  | 25d | 2011-07-29 | 2011-09-01 | 13455055 FS-25d, 13455050 | 109d | 23d |  | MECH TECH [60 h]; MECH ENG [8 h] | 3,127.8 | BEVINS M | 1 | 1 |  | MIKE B |  |  |  | 10-030 |  |  |  |  |  |  | 12-018F |  |  |  |  | 11-026 |  |  |  |  |  |  |  |  |  |  |  |  |
| 13454055 |  | 100 kW dump Modifications (ARC10/H-D Stands) Revised |  | 76d | 2011-11-02 | 2012-02-29 | 9-120M FS+22d | 407d |  |  | MECH TECH [120 h]; MECH DES [120 h]; MECH ENG [180 h]; PROCUREMENT<$50K 60 | 46,095.97 | BEVINS M | 1 | 1 |  | MIKE B | 08-029 | 09-012 |  | 10-030 |  |  |  |  |  |  |  |  | 11-057 |  |  |  |  |  |  |  |  |  |  |  |  |  |  |  |
| 13454040 |  | Vend Fab Insertable Dumps (ARC10/H-D Stands) |  | 117d | 2012-01-13 | 2012-06-29 | 9-120M FS+66d, 13454036 | 17d |  |  | PROCUREMENT<$50K 60 | 25,740.14 | BEVINS M | 1 | 1 |  | MIKE B | 08-029 |  |  | 10-030 |  |  |  |  |  |  |  |  | 11-057 |  |  |  |  |  |  |  |  |  |  |  |  |  |  |  |
| 13455080M |  | Award Hall D Stands | milestone | 0d | 2012-01-17 | 2012-01-17 | 13455080, 9-120M FS+68d | 324d | 0d |  |  |  | BEVINS M | 1 | 1 |  | MIKE B |  |  |  | 10-030 | 10-065 |  | 6 | 10-070 | 12-035F |  | 12-018F |  | 11-057 |  |  |  |  |  |  |  |  |  |  |  |  |  |  |  |
| 13455085LOE |  | Vend Fab Hall D Stands Oversight |  | 73d | 2012-01-18 | 2012-04-30 | 13455080M | 411d | 184d |  | MECH ENG [20 h]; MECH DES [50 h] | 3,810.9 | BEVINS M | 1 | 1 |  | MIKE B |  |  |  | 10-030 | 10-065 |  |  | 10-070 | 12-035F |  | 12-018F |  | 11-057 |  |  |  |  |  |  |  |  |  |  |  |  |  |  |  |
| 13455105 |  | Receive and Inspect Hall DStands |  | 39d | 2012-03-07 | 2012-04-30 | 13455090 FS-126d | 416d | 92d |  | MECH ENG [20 h]; MECH TECH [70 h] | 4,513.2 | BEVINS M | 1 | 1 |  | MIKE B |  |  |  | 10-030 | 10-065 |  |  | 10-070 | 12-035F |  | 12-018F |  | 11-057 |  |  |  |  |  |  |  |  |  |  |  |  |  |  |  |
| 13455090 |  | Vend Fab Hall D Stands |  | 60d | 2012-06-11 | 2012-08-31 | 13455080M FS+100d | 324d | 0d |  | PROCUREMENT>$50K 69; PROCUREMENT<$50K 60 | 88,823.6 | BEVINS M | 1 | 1 |  | MIKE B |  |  |  | 10-030 | 10-065 |  |  | 10-070 | 12-035 |  | 12-018F |  | 11-057 |  |  |  | 12-039 |  |  |  |  |  |  |  |  |  |  |  |
| 13455110M |  | Delivery Complete for Hall D Stands | milestone | 0d | 2012-08-31 | 2012-08-31 | 13455105 FS-5d, 13455090 | 324d | 97d |  |  |  | BEVINS M | 1 | 1 |  | MIKE B |  |  |  | 10-030 | 10-065 |  | 6 | 10-070 | 12-035 |  | 12-018F |  | 11-057 |  |  |  |  |  |  |  |  |  |  |  |  |  |  |  |
| 13454060 |  | Re-Baseline Actuals Adjustment |  | 1d | 2013-08-30 | 2013-08-30 | 9-130M FS+227d | 20d |  |  | PROCUREMENT>$50K 69 NO ESCALATION | 102,433.65 | BEVINS M | 1 | 1 |  | MIKE B |  |  |  |  |  |  |  |  |  |  |  |  |  |  |  |  |  | 13-014 | ADJ |  |  |  |  |  |  |  |  |  |
| 23454055 |  | 100 kW dump Modifications (ARC10/H-D Stands) Procurement |  | 37d | 2013-09-03 | 2013-10-23 | 9-130M FS+228d | 13d |  | 8/5 M-F w/JLAB Holidays ReBaseline | MECH TECH; MECH DES; MECH ENG; SUPPLIES & MATERIALS; PROCUREMENT<$50K 60 NO ESCALATION FY14 | 2,999.36 | BEVINS M | 1 | 1 |  | MIKE B | 08-029 | 09-012 |  | 10-030 |  |  |  |  |  |  |  |  | 11-057 |  |  |  |  |  |  | 23454055 | y | S | EJ | EJ | 13-015 | PR | OB |  |
| 23454055a |  | 100 kW dump Modifications (ARC10/H-D Stands) Labor/Expenses FY13 |  | 20d | 2013-09-03 | 2013-09-30 | 9-130M FS+228d | 13d | 0d | 8/5 M-F w/JLAB Holidays ReBaseline | MECH TECH [19.46 h]; MECH DES [19.46 h]; MECH ENG [29.19 h]; SUPPLIES & MATERIALS | 11,409.83 | BEVINS M | 1 | 1 |  | MIKE B | 08-029 | 09-012 |  | 10-030 |  |  |  |  |  |  |  |  | 11-057 |  |  |  |  |  |  | 23454055 |  | S | EJ | EJ | 13-015 | PR |  |  |
| 23454055b |  | 100 kW dump Modifications (ARC10/H-D Stands) Labor/Expenses FY14 |  | 17d | 2013-10-01 | 2013-10-23 | 23454055a, 9-130M FS+228d | 13d |  | 8/5 M-F w/JLAB Holidays ReBaseline | MECH TECH [16.54 h]; MECH DES [16.54 h]; MECH ENG [24.81 h]; SUPPLIES & MATERIALS | 10,007.57 | BEVINS M | 1 | 1 |  | MIKE B | 08-029 | 09-012 |  | 10-030 |  |  |  |  |  |  |  |  | 11-057 |  |  |  |  |  |  | 23454055 |  | S | EJ | EJ | 13-015 | PR |  | 14-001 |

Notes:
- 23454055: Explanation: $2,999 is for stands
- 23454055a: Explanation: $2,999 is for stands
- 23454055b: Explanation: $2,999 is for stands

| ID | WBS | Activity | Type | Duration | Start | Finish | Predecessors | Total float | Free float | Calendar | Resources | Cost | RESP - Responsibility | STRT%COMP for CM EVM | FNSH%COMP for CM EVM | CAM RESPONSIBLE | CR 10-030 | CR 10-065 | CR 11-026 | CR 12-018 | Profile change | Milestone Level | CR 11-001 | CR 10-070 | CR 12-035 | CR 08-029 | CR 09-012 | CR 08-051 | CR 11-057 | CR 13-014 | ReBaseline Actuals Adjustment | Duplications | CR 08-016 | CR 10-059 | Original Activity ID Rebaseline | EVMS Reporting Codes | BOE Labor | CR 13-015 | Post Rebaseline | CR 14-001 |
| --- | --- | --- | --- | --- | --- | --- | --- | --- | --- | --- | --- | --- | --- | --- | --- | --- | --- | --- | --- | --- | --- | --- | --- | --- | --- | --- | --- | --- | --- | --- | --- | --- | --- | --- | --- | --- | --- | --- | --- | --- |
|  | 5 | **1.3.4.5.5 GIRDERS** |  |  |  |  |  |  |  |  |  |  |  |  |  |  |  |  |  |  |  |  |  |  |  |  |  |  |  |  |  |  |  |  |  |  |  |  |  |  |
|  | 6 | **1.3.4.5.6 VACUUM** |  |  | 2010-04-14 | 2013-08-30 |  |  |  |  |  |  |  |  |  |  |  |  |  |  |  |  |  |  |  |  |  |  |  |  |  |  |  |  |  |  |  |  |  |  |
| 13456032 |  | Prcrmnt Prep of Ion Pumps & Vac Valves (ARC 10/H-D Vac) |  | 44d | 2010-04-14 | 2010-06-15 | 9-100M FS+129d | 254d | 0d |  | MECH DES [40 h]; MECH ENG [80 h] | 7,077.6 | BEVINS M | 1 | 1 | MIKE B | 10-030 | 10-065 | 11-026 | 12-018F |  |  |  |  |  |  |  |  |  |  |  |  |  |  |  |  |  |  |  |  |
| 13456037 |  | Prcrmnt Prep of Bellows & Drift tubes (ARC 10/H-D Vac) |  | 58d | 2010-05-11 | 2010-08-02 | 9-100M FS+148d | 9d | 0d |  | MECH ENG [80 h]; MECH DES [60 h] | 7,982.4 | BEVINS M | 1 | 1 | MIKE B | 10-030 | 10-065 |  |  | C |  |  |  |  |  |  |  |  |  |  |  |  |  |  |  |  |  |  |  |
| 13456020M |  | Award Contract for Dipole Chambers (ARC 10/H-D VACUUM) | milestone | 0d | 2010-07-30 | 2010-07-30 | 13456015 FS-94d | 232d | 0d |  |  |  | BEVINS M | 1 | 1 | MIKE B | 10-030 |  |  |  |  | 6 |  |  |  |  |  |  |  |  |  |  |  |  |  |  |  |  |  |  |
| 13456022LOE |  | Vend Fab Dipole Chambers (ARC 10/H-D Vac) Oversight FY10 |  | 44d | 2010-07-30 | 2010-09-30 | 13456020M | 292d | 0d |  | MECH DES [11.73 h]; MECH ENG [23.47 h] | 2,076.17 | BEVINS M | 1 | 1 | MIKE B | 10-030 |  |  |  |  |  | 11-001 |  |  |  |  |  |  |  |  |  |  |  |  |  |  |  |  |  |
| 13456025 |  | Vend Fab Dipole Chambers (ARC 10/H-D Vac) Phase 1 |  | 80d | 2010-07-30 | 2010-11-19 | 13456020M | 232d | 0d |  | PROCUREMENT<$50K 60 NO ESCALATION FY11 | 33,879 | BEVINS M | 1 | 1 | MIKE B | 10-030 |  |  |  |  |  |  |  |  |  |  |  |  |  |  |  |  |  |  |  |  |  |  |  |
| 13456027 |  | Vend Fab Dipole Chambers (ARC 10/H-D Vac) Phase 2 |  | 112d | 2010-07-30 | 2011-01-14 | 13456025 FS-80d | 292d | 0d |  | PROCUREMENT<$50K 60 NO ESCALATION FY11; PROCUREMENT>$50K 69 NO ESCALATION FY11 | 33,879 | BEVINS M | 1 | 1 | MIKE B | 10-030 |  |  | 12-018F |  |  |  | 10-070 | 12-035F |  |  |  |  |  |  |  |  |  |  |  |  |  |  |  |
| 13456028 |  | Vend Fab Dipole Chambers (ARC 10/H-D Vac) Phase 3 |  | 150d | 2010-07-30 | 2011-03-11 | 13456027 FS-112d | 292d | 0d |  | PROCUREMENT>$50K 69 NO ESCALATION FY11 | 33,879 | BEVINS M | 1 | 1 | MIKE B | 10-030 |  |  | 12-018F |  |  |  | 10-070 | 12-035F |  |  |  |  |  |  |  |  |  |  |  |  |  |  |  |
| 13456035 |  | Prcrmnt of Ion Pumps & Vac Valves (ARC 10/H-D Vac) |  | 98d | 2010-09-10 | 2011-02-07 | 13456032 FS+60d | 254d | 168d |  | PROCUREMENT<$50K 60 NO ESCALATION FY11 | 105,922.9 | BEVINS M | 1 | 1 | MIKE B | 10-030 | 10-065 | 11-026 | 12-018F |  |  |  |  |  |  |  |  |  |  |  |  |  |  |  |  |  |  |  |  |
| 13456040 |  | Prcrmnt of Bellows & Drift tubes (ARC 10/H-D Vac) |  | 92d | 2010-09-29 | 2011-02-16 | 13456037 FS+40d | 9d | 0d |  | PROCUREMENT<$50K 60 NO ESCALATION FY11 | 59,935 | BEVINS M | 1 | 1 | MIKE B | 10-030 | 10-065 |  |  | C |  |  |  |  | 08-029 | 09-012 |  |  |  |  |  |  |  |  |  |  |  |  |  |
| 13456015 |  | Prcrmnt Prep for Dipole Chambers (ARC 10/H-D Vac) |  | 50d | 2010-10-01 | 2010-12-13 | 121456999, 9-110M, 121456015 | 232d | 0d |  | MECH ENG [120 h]; MECH DES [20 h] | 9,087.6 | BEVINS M | 1 | 1 | MIKE B |  |  |  |  |  |  |  |  |  |  |  |  |  |  |  |  |  |  |  |  |  |  |  |  |
| 13456022LOEa |  | Vend Fab Dipole Chambers (ARC 10/H-D Vac) Oversight FY11 |  | 106d | 2010-10-01 | 2011-03-11 | 13456022LOE | 292d |  |  | MECH ENG [56.53 h]; MECH DES [28.27 h] | 5,160.85 | BEVINS M | 1 | 1 | MIKE B | 10-030 |  |  |  |  |  | 11-001 |  |  |  |  |  |  |  |  |  |  |  |  |  |  |  |  |  |
| 13456030M |  | Delivery Complete for Dipole Chambers (ARC 10/H-D VACUUM) | milestone | 0d | 2010-11-19 | 2010-11-19 | 13456025 | 232d |  |  |  |  | BEVINS M | 1 | 1 | MIKE B | 10-030 |  |  |  |  | 6 |  |  |  |  |  |  |  |  |  |  |  |  |  |  |  |  |  |  |
| 13456029 |  | Receive and Inspect Dipole Chambers (ARC 10/H-D Vac) |  | 70d | 2010-11-22 | 2011-03-11 | 13456025, 13456028 FS-70d | 292d |  |  | MECH ENG [20 h]; MECH TECH [80 h] | 4,804.6 | BEVINS M | 1 | 1 | MIKE B | 10-030 |  |  | 12-018F |  |  |  | 10-070 | 12-035F |  |  |  |  |  |  |  |  |  |  |  |  |  |  |  |
| 13456045 |  | Assemble Quad Girders for Arc10 & Hall D on Floor (ARC 10/H-D Vac) |  | 101d | 2010-11-30 | 2011-04-29 | 13455030 FS-10d, 13455023a, 13455035, 13456040 FS-50d, 13455015, 13455020 | 9d |  |  | MECH ENG [40 h]; MECH TECH [760 h]; MECH DES [60 h]; PROCUREMENT<$50K 60 | 62,063.09 | BEVINS M | 1 | 1 | MIKE B | 10-030 | 10-065 |  |  |  |  |  |  |  | 08-029 |  | 08-051 |  |  |  |  |  |  |  |  |  |  |  |  |
| 13456047 |  | Assemble Quad Girders for Arc10 & Hall D (ARC 10/H-D Vac) |  | 101d | 2011-10-06 | 2012-03-08 | 9-120M FS+3d, 13455010, 13456035, 13456040 FS-50d, 13452045b FS-150d, 13452050, 13455020, 13453030, 13455015, 13452045a FS-150d, 13455060, 13455045, 13455030, 13452050a, 13455023a | 86d |  |  | MECH ENG [40 h]; MECH TECH [290 h]; MECH DES [60 h]; PROCUREMENT<$50K 60 | 20,923.07 | BEVINS M | 1 | 1 | MIKE B | 10-030 |  | 11-026 | 12-018F |  |  |  |  |  |  |  |  |  |  |  |  |  |  |  |  |  |  |  |  |
| 13456042 |  | Prcrmnt of Hall D Drift tubes (ARC 10/H-D Vac) |  | 52d | 2012-02-16 | 2012-04-30 | 9-120M FS+89d | 9d |  |  | PROCUREMENT<$50K 60 | 37,268.62 | BEVINS M | 1 | 1 | MIKE B | 10-030 |  | 11-026 |  | C |  |  |  |  |  |  |  | 11-057 |  |  |  |  |  |  |  |  |  |  |  |
| 13456050 |  | Re-Baseline Actuals Adjustment |  | 1d | 2013-08-30 | 2013-08-30 | 9-130M FS+227d | 20d |  |  | PROCUREMENT>$50K 69 NO ESCALATION | 51,938.43 | BEVINS M | 1 | 1 | MIKE B |  |  |  |  |  |  |  |  |  |  |  |  |  | 13-014 | ADJ |  |  |  |  |  |  |  |  |  |
|  | 7 | **1.3.4.5.7 LCW & INSTRUMENT AIR** |  |  |  |  |  |  |  |  |  |  |  |  |  |  |  |  |  |  |  |  |  |  |  |  |  |  |  |  |  |  |  |  |  |  |  |  |  |  |
|  | 8 | **1.3.4.5.8 INSTALLATION** |  |  | 2011-05-13 | 2013-10-23 |  |  |  |  |  |  |  |  |  |  |  |  |  |  |  |  |  |  |  |  |  |  |  |  |  |  |  |  |  |  |  |  |  |  |
| 13458030 |  | Remove North Stub dump & Steel (ARC 10/H-D Installtn) |  | 35d | 2011-05-13 | 2011-07-01 | 4A-01M | 549d | 0d |  |  |  | BEVINS M | 1 | 1 | MIKE B | 10-030 |  |  |  |  |  |  |  |  | 08-029 | 09-012 |  | 11-057 |  |  | DUP |  |  |  |  |  |  |  |  |
| 13458012 |  | Install Stands in Arc 10 Phase 2 |  | 64d | 2011-05-17 | 2011-08-16 | 13454030M, 13454035, 4A-01M FS+2d, 13455125 | 499d | 369d |  | MECH DES [60 h]; MECH TECH [232 h]; MECH ENG [44 h] | 15,782.84 | BEVINS M | 1 | 1 | MIKE B | 10-030 | 10-065 |  |  |  |  |  | 10-070 | 12-035F |  |  |  |  |  |  |  |  |  |  |  |  |  |  |  |
| 13458010 |  | Install Stands in Arc 10 Phase 1 |  | 65d | 2011-06-27 | 2011-09-27 | 13454030M, 13454035, 13454022LOE, 4A-01M FS+30d, 9-110M | 470d | 340d |  | MECH DES [20 h]; MECH ENG [16 h]; MECH TECH [80 h]; PROCUREMENT<$50K 60 | 5,905.92 | BEVINS M | 1 | 1 | MIKE B | 10-030 | 10-065 |  |  |  |  |  | 10-070 | 12-035F | 08-029 |  |  |  |  |  |  |  |  |  |  |  |  |  |  |
| 13458040 |  | Arc 10 Installation Completion |  | 90d | 2012-10-01 | 2013-02-14 | 9-130M | 130d | 0d |  | MECH ENG [156 h]; MECH TECH [688 h] | 42,839.84 | BEVINS M | 1 | 1 | MIKE B | 10-030 | 10-065 |  | 12-018F |  |  |  | 10-070 | 12-035 | 08-029 | 09-012 | 08-051 |  |  |  |  | 08-016 | 10-059 |  |  |  |  |  |  |
| 13458050 |  | Hall D - Green door install |  | 25d | 2012-10-01 | 2012-11-02 | 9-130M | 353d | 0d |  | MECH ENG [68 h]; MECH TECH [304 h] | 18,861.92 | BEVINS M | 1 | 1 | MIKE B |  | 10-065 |  |  |  |  |  |  | 12-035 |  |  |  |  |  |  |  |  |  |  |  |  |  |  |  |
| 13458055 |  | Hall D - Install Stands |  | 22d | 2013-01-30 | 2013-03-01 | 13454032, 13455110M, 3A-12M, 9-130M FS+78d, 13455085LOE | 227d | 0d |  | MECH TECH [488 h]; MECH ENG [108 h] | 30,194.56 | BEVINS M | 1 | 1 | MIKE B |  | 10-065 |  |  |  |  |  |  | 12-035 |  |  |  |  |  |  |  |  |  |  |  |  |  |  |  |
| 13458060 |  | Hall D - Install magnets and girders |  | 46d | 2013-03-04 | 2013-05-06 | 13458055 | 227d | 0d |  | MECH TECH [928 h]; MECH ENG [208 h] | 57,608.96 | BEVINS M | 1 | 1 | MIKE B |  | 10-065 |  |  |  |  |  |  | 12-035 |  |  |  |  |  |  |  |  |  |  |  |  |  |  |  |
| 13458045 |  | Hall D - Tagger dump installation |  | 32d | 2013-04-04 | 2013-05-17 | 2-16M, 16331032, 16331030, 9-130M FS+123d, 2-17M | 82d |  |  | MECH ENG [176 h]; MECH TECH [784 h] | 48,689.6 | BEVINS M | 1 | 1 | MIKE B | 10-030 | 10-065 |  |  |  |  |  |  | 12-035 | 08-029 |  |  |  |  |  |  |  | 10-059 |  |  |  |  |  |  |
| 13458065 |  | Hall D - Final align |  | 5d | 2013-05-07 | 2013-05-13 | 13458060 | 227d | 182d |  |  |  | BEVINS M | 1 | 1 | MIKE B |  | 10-065 |  |  |  |  |  |  | 12-035 |  |  |  |  |  |  |  |  |  |  |  |  |  |  |  |
| 13458070 |  | Re-Baseline Actuals Adjustment |  | 1d | 2013-08-30 | 2013-08-30 | 9-130M FS+227d | 20d |  |  | PROCUREMENT>$50K 69 NO ESCALATION | 131,684.5 | BEVINS M | 1 | 1 | MIKE B |  |  |  |  |  |  |  |  |  |  |  |  |  | 13-014 | ADJ |  |  |  |  |  |  |  |  |  |
| 23458040 |  | Arc 10 Installation Completion FY13 |  | 20d | 2013-09-03 | 2013-09-30 | 9-130M FS+228d | 31d | 0d | 8/5 M-F w/JLAB Holidays ReBaseline | MECH ENG [101.33 h]; MECH TECH [304 h] | 21,273.75 | BEVINS M | 1 | 1 | MIKE B | 10-030 | 10-065 |  | 12-018F |  |  |  | 10-070 | 12-035 | 08-029 | 09-012 | 08-051 |  |  |  |  | 08-016 | 10-059 | 23458040 | S | PE | 13-015 | PR |  |
| 23458060 |  | Hall D - Install magnets and girders FY13 |  | 20d | 2013-09-03 | 2013-09-30 | 9-130M FS+228d | 35d | 0d | 8/5 M-F w/JLAB Holidays ReBaseline | MECH TECH [98.71 h]; MECH ENG [24.68 h] | 6,312.63 | BEVINS M | 1 | 1 | MIKE B |  | 10-065 |  |  |  |  |  |  | 12-035 |  |  |  |  |  |  |  |  |  | 23458060 | H | PE | 13-015 | PR |  |
| 23458045 |  | Hall D - Tagger dump installation FY13 |  | 4d | 2013-09-25 | 2013-09-30 | 9-130M FS+244d | 90d | 0d | 8/5 M-F w/JLAB Holidays ReBaseline | MECH ENG [38.48 h]; MECH TECH [153.9 h] | 9,842.16 | BEVINS M | 1 | 1 | MIKE B | 10-030 | 10-065 |  |  |  |  |  |  | 12-035 | 08-029 |  |  |  |  |  |  |  | 10-059 | 23458045 | S | PE | 13-015 | PR |  |
| 23458065 |  | Hall D - Final align FY13 |  | 4d | 2013-09-25 | 2013-09-30 | 23458060a FS-7d, 23458060 FS-7d | 35d | 0d | 8/5 M-F w/JLAB Holidays ReBaseline | MECH TECH [83.2 h]; MECH ENG [20.8 h] | 5,320.64 | BEVINS M | 1 | 1 | MIKE B |  | 10-065 |  |  |  |  |  |  | 12-035 |  |  |  |  |  |  |  |  |  | 23458065 | H | PE | 13-015 | PR |  |
| 23458040a |  | Arc 10 Installation Completion FY14 |  | 10d | 2013-10-01 | 2013-10-14 | 9-130M FS+228d, 23458040 | 31d | 20d | 8/5 M-F w/JLAB Holidays ReBaseline | MECH ENG [50.67 h]; MECH TECH [152 h] | 10,976.1 | BEVINS M | 1 | 1 | MIKE B | 10-030 | 10-065 |  | 12-018F |  |  |  | 10-070 | 12-035 | 08-029 | 09-012 | 08-051 |  |  |  |  | 08-016 | 10-059 | 23458040 | S | PE | 13-015 | PR | 14-001 |
| 23458045a |  | Hall D - Tagger dump installation FY14 |  | 17d | 2013-10-01 | 2013-10-23 | 9-130M FS+244d, 23458045 | 90d | 30d | 8/5 M-F w/JLAB Holidays ReBaseline | MECH ENG [163.52 h]; MECH TECH [654.1 h] | 43,162.16 | BEVINS M | 1 | 1 | MIKE B | 10-030 | 10-065 |  |  |  |  |  |  | 12-035 | 08-029 |  |  |  |  |  |  |  | 10-059 | 23458045 | S | PE | 13-015 | PR | 14-001 |
| 23458060a |  | Hall D - Install magnets and girders FY14 |  | 3d | 2013-10-01 | 2013-10-03 | 23458060, 9-130M FS+228d | 35d | 0d | 8/5 M-F w/JLAB Holidays ReBaseline | MECH TECH [14.81 h]; MECH ENG [3.7 h] | 977.14 | BEVINS M | 1 | 1 | MIKE B |  | 10-065 |  |  |  |  |  |  | 12-035 |  |  |  |  |  |  |  |  |  | 23458060 | H | PE | 13-015 | PR | 14-001 |
| 23458065a |  | Hall D - Final align FY14 |  | 1d | 2013-10-01 | 2013-10-01 | 23458060a FS-7d, 23458065, 23458060 FS-7d | 35d | 5d | 8/5 M-F w/JLAB Holidays ReBaseline | MECH TECH [20.8 h]; MECH ENG [5.2 h] | 1,372.54 | BEVINS M | 1 | 1 | MIKE B |  | 10-065 |  |  |  |  |  |  | 12-035 |  |  |  |  |  |  |  |  |  | 23458065 | H | PE | 13-015 | PR | 14-001 |

Notes:
- 13458030: Explanation: Corrected finish time to 16:00 which affected several other activities which / are now tagged with CR10-030 PMK 15 March 10

| ID | WBS | Activity | Type | Duration | Start | Finish | Predecessors | Total float | Free float | Calendar | Resources | Cost | RESP - Responsibility | STRT%COMP for CM EVM | FNSH%COMP for CM EVM | CAM RESPONSIBLE | CR 11-028 | CR 11-057 | CR 12-029 | CR 12-035 | Milestone Level | CR 13-014 | ReBaseline Actuals Adjustment | CR 12-001 | CR 12-039 | CR 12-053 | Original Activity ID Rebaseline | EVMS Reporting Codes | BOE Labor | CR 13-015 | Post Rebaseline | CR 14-001 |
| --- | --- | --- | --- | --- | --- | --- | --- | --- | --- | --- | --- | --- | --- | --- | --- | --- | --- | --- | --- | --- | --- | --- | --- | --- | --- | --- | --- | --- | --- | --- | --- | --- |
|  | 6 | **1.3.4.6 EXTRACTION** |  |  | 2011-04-01 | 2013-10-09 |  |  |  |  |  |  |  |  |  |  |  |  |  |  |  |  |  |  |  |  |  |  |  |  |  |  |
|  | 1 | **1.3.4.6.1 LAMBERTSON** |  |  | 2011-04-01 | 2013-08-30 |  |  |  |  |  |  |  |  |  |  |  |  |  |  |  |  |  |  |  |  |  |  |  |  |  |  |
| 13461050LOE |  | FY11 Engrng Oversight (LAMBERTSON) |  | 128d | 2011-04-01 | 2011-09-30 | 9-110M FS+120d | 20d | 0d |  | MECH ENG [41.29 h]; TRAVEL | 4,561.27 | BEVINS M | 1 | 1 | MIKE B | 11-028 |  |  |  |  |  |  |  |  |  |  |  |  |  |  |  |
| 13461015 |  | Machine Lambertson Mag Iron MATL (LAMBERTSON) |  | 56d | 2011-10-03 | 2011-12-21 | 13461010 FS-70d | 451d | 219d |  | PROCUREMENT<$50K 60 | 7,020.05 | BEVINS M | 1 | 1 | MIKE B | 11-028 | 11-057 | 12-029F | 12-035F |  |  |  |  |  |  |  |  |  |  |  |  |
| 13461000 |  | Proc Coil Packs for Lambertson LABOR (LAMBERTSON) |  | 64d | 2012-01-05 | 2012-04-05 | 12154020M, 9-120M FS+60d | 383d | 0d |  | MECH ENG [140 h]; MECH DES [60 h] | 12,707 | BEVINS M | 1 | 1 | MIKE B | 11-028 |  | 12-029F | 12-035F |  |  |  |  |  |  |  |  |  |  |  |  |
| 13461005 |  | Proc Coil Packs for Lambertson MATL (LAMBERTSON) |  | 64d | 2012-01-05 | 2012-04-05 | 13461000 FS-64d | 383d | 151d |  | PROCUREMENT<$50K 60 | 36,855.18 | BEVINS M | 1 | 1 | MIKE B | 11-028 |  | 12-029F | 12-035F |  |  |  |  |  |  |  |  |  |  |  |  |
| 13461010 |  | Machine Lambertson Mag Iron LABOR (LAMBERTSON) |  | 10d | 2012-01-05 | 2012-01-19 | 9-120M FS+60d | 451d | 0d |  | MECH DES [60 h]; MECH ENG [60 h] | 7,097.4 | BEVINS M | 1 | 1 | MIKE B | 11-028 | 11-057 | 12-029F | 12-035F |  |  |  |  |  |  |  |  |  |  |  |  |
| 13461025 |  | Install Lambertson Coil pack (LAMBERTSON) |  | 5d | 2012-11-08 | 2012-11-14 | 13461005, 2-02M FS+125d, 13461015 | 232d | 0d |  | MECH TECH [120 h]; MECH ENG [40 h]; MECH DES [40 h] | 10,386 | BEVINS M | 1 | 1 | MIKE B | 11-028 |  | 12-029F | 12-035 |  |  |  |  |  |  |  |  |  |  |  |  |
| 13461020 |  | Lambertson Mag measurements (LAMBERTSON) |  | 5d | 2012-11-15 | 2012-11-21 | 9-130M FS+30d, 13461025 | 232d | 0d |  | MECH TECH [40 h]; MECH ENG [20 h] | 3,281.6 | BEVINS M | 1 | 1 | MIKE B | 11-028 |  | 12-029F | 12-035 |  |  |  |  |  |  |  |  |  |  |  |  |
| 13461035 |  | Install New Lambertson MATL (LAMBERTSON) |  | 5d | 2012-11-26 | 2012-11-30 | 13461025, 13461020 | 232d | 0d |  | PROCUREMENT<$50K 60 | 6,881.78 | BEVINS M | 1 | 1 | MIKE B | 11-028 |  | 12-029F | 12-035 |  |  |  |  |  |  |  |  |  |  |  |  |
| 13461040 |  | Test New Lambertson (LAMBERTSON) |  | 5d | 2012-12-03 | 2012-12-07 | 13461035 | 232d | 0d |  | ELEC TECH [20 h] | 910.8 | BEVINS M | 1 | 1 | MIKE B | 11-028 |  | 12-029F | 12-035 |  |  |  |  |  |  |  |  |  |  |  |  |
| 13461045M |  | Ready for Beam Commssng (LAMBERTSON) | milestone | 0d | 2012-12-07 | 2012-12-07 | 13461040 | 232d |  |  |  |  | BEVINS M | 1 | 1 | MIKE B | 11-028 |  | 12-029F | 12-035 | 6 |  |  |  |  |  |  |  |  |  |  |  |
| 13461055 |  | Re-Baseline Actuals Adjustment |  | 1d | 2013-08-30 | 2013-08-30 | 9-130M FS+227d | 20d |  |  | PROCUREMENT>$50K 69 NO ESCALATION | -67,098.24 | BEVINS M | 1 | 1 | MIKE B |  |  |  |  |  | 13-014 | ADJ |  |  |  |  |  |  |  |  |  |
|  | 2 | **1.3.4.6.2 CHICANE** |  |  | 2011-04-01 | 2013-08-30 |  |  |  |  |  |  |  |  |  |  |  |  |  |  |  |  |  |  |  |  |  |  |  |  |  |  |
| 13462000 |  | Fab Dipole Magnets (CHICANE) Original Labor FY11 |  | 128d | 2011-04-01 | 2011-09-30 | 1355040a | 233d | 0d |  | MECH ENG [75.94 h]; MECH DES [31.06 h] | 6,610 | BEVINS M | 1 | 1 | MIKE B | 11-028 |  |  | 12-035F |  |  |  | 12-001 |  |  |  |  |  |  |  |  |
| 13462015LOE |  | FY11 Mech Eng/Dsgner Oversight (CHICANE) |  | 128d | 2011-04-01 | 2011-09-30 | 9-110M FS+120d | 20d | 0d |  | TRAVEL | 2,340.81 | BEVINS M | 1 | 1 | MIKE B | 11-028 |  |  |  |  |  |  |  |  |  |  |  |  |  |  |  |
| 13462000a |  | Fab Dipole Magnets (CHICANE) Original Labor FY12 |  | 84d | 2011-10-03 | 2012-02-08 | 13462000 | 233d | 0d |  | MECH ENG [49.83 h]; MECH DES [20.39 h] | 4,476.27 | BEVINS M | 1 | 1 | MIKE B | 11-028 |  |  | 12-035F |  |  |  | 12-001 |  |  |  |  |  |  |  |  |
| 13462005 |  | Measure Dipole Magnets (CHICANE) (IPL 534213060 and 534213120) |  | 65d | 2012-02-09 | 2012-05-10 | 13411105u, 13411105t, 13462000a | 233d | 0d |  | MECH TECH [80 h]; MECH ENG [40 h] | 6,360 | BEVINS M | 1 | 1 | MIKE B | 11-028 |  |  | 12-035F |  |  |  |  |  |  |  |  |  |  |  |  |
| 13462010M |  | Extraction Dipoles Ready for Installtn (CHICANE) | milestone | 0d | 2012-05-10 | 2012-05-10 | 13462005 | 233d | 131d |  |  |  | BEVINS M | 1 | 1 | MIKE B | 11-028 |  |  | 12-035F | 6 |  |  |  |  |  |  |  |  |  |  |  |
| 13462020 |  | Re-Baseline Actuals Adjustment |  | 1d | 2013-08-30 | 2013-08-30 | 9-130M FS+227d | 20d |  |  | PROCUREMENT>$50K 69 NO ESCALATION | -9,920.24 | BEVINS M | 1 | 1 | MIKE B |  |  |  |  |  | 13-014 | ADJ |  |  |  |  |  |  |  |  |  |
|  | 3 | **1.3.4.6.3 STANDS** |  |  | 2012-01-03 | 2013-10-09 |  |  |  |  |  |  |  |  |  |  |  |  |  |  |  |  |  |  |  |  |  |  |  |  |  |  |
| 13463005 |  | Fab Stands LABOR (Stands) |  | 86d | 2012-01-03 | 2012-05-03 | 13463000 FS-86d | 173d | 0d |  | MECH DES [4 h]; MECH ENG [4 h] | 473.16 | BEVINS M | 1 | 1 | MIKE B | 11-028 |  |  | 12-035F |  |  |  |  |  |  |  |  |  |  |  |  |
| 13463010 |  | Fab Stands MATL (Stands) Frozen Per CR12-039 |  | 83d | 2012-01-03 | 2012-04-30 | 13463005 FS-86d | 176d | 74d |  | PROCUREMENT<$50K 60 | 16,907.95 | BEVINS M | 1 | 1 | MIKE B | 11-028 |  |  | 12-035F |  |  |  |  | 12-039 |  |  |  |  |  |  |  |
| 13463045LOE |  | FY12 Mech Eng/Dsgner Oversight (Stands) |  | 187d | 2012-01-05 | 2012-09-28 | 9-120M FS+60d | 20d | 0d |  | TRAVEL | 1,207.76 | BEVINS M | 1 | 1 | MIKE B | 11-028 |  |  |  |  |  |  |  |  |  |  |  |  |  |  |  |
| 13463000 |  | Insp Matls (Stands) |  | 15d | 2012-04-13 | 2012-05-03 | 1356020, 9-120M FS+129d, 1356018 | 173d | 0d |  | MECH ENG [5.4 h]; MECH TECH [18 h] | 1,178.57 | BEVINS M | 1 | 1 | MIKE B | 11-028 |  |  | 12-035F |  |  |  |  |  |  |  |  |  |  |  |  |
| 13463012 |  | Reverse Entry Per CR12-039 |  | 3d | 2012-05-01 | 2012-05-03 | 9-120M FS+141d | 103d |  |  | PROCUREMENT<$50K 60 | -16,907.95 | BEVINS M | 1 | 1 | MIKE B | 11-028 |  |  | 12-035F |  |  |  |  | 12-039 |  |  |  |  |  |  |  |
| 13463013 |  | Fab Stands MATL (Stands) Revised Per CR12-039 |  | 3d | 2012-05-01 | 2012-05-03 | 13463005 FS-3d | 173d | 71d |  | PROCUREMENT<$50K 60 | 15,926.29 | BEVINS M | 1 | 1 | MIKE B | 11-028 |  |  | 12-035F |  |  |  |  | 12-039 |  |  |  |  |  |  |  |
| 13463015 |  | Extraction - Remove |  | 32d | 2012-08-15 | 2012-09-28 | 2-02M FS+65d, 13463010, 13463013 | 102d | 0d |  | MECH TECH [792 h]; MECH ENG [572 h] | 75,305.12 | BEVINS M | 1 | 1 | MIKE B | 11-028 |  |  | 12-035 |  |  |  |  |  |  |  |  |  |  |  |  |
| 13463035 |  | Extraction - Upstairs FY12 |  | 20d | 2012-08-31 | 2012-09-28 | 13463015 FS-20d | 140d | 0d |  | MECH TECH [445.41 h]; MECH ENG [220.54 h] | 35,258.28 | BEVINS M | 1 | 1 | MIKE B | 11-028 |  |  | 12-035 |  |  |  |  |  | 12-053 |  |  |  |  |  |  |
| 13463035a |  | Extraction - Upstairs FY13 |  | 17d | 2012-10-01 | 2012-10-23 | 13463035 | 140d | 38d |  | MECH TECH [378.59 h]; MECH ENG [187.46 h] | 30,926.75 | BEVINS M | 1 | 1 | MIKE B | 11-028 |  |  | 12-035 |  |  |  |  |  | 12-053 |  |  |  |  |  |  |
| 13463020 |  | Install Stands MATL (Stands) |  | 22d | 2012-11-15 | 2012-12-18 | 13463015 FS+33d | 102d | 0d |  | PROCUREMENT<$50K 60 | 4,708.58 | BEVINS M | 1 | 1 | MIKE B | 11-028 |  |  | 12-035 |  |  |  |  |  |  |  |  |  |  |  |  |
| 13463025 |  | Extraction - Install stands |  | 22d | 2012-11-15 | 2012-12-18 | 13463020 FS-22d, 1355025M, 13463015, 13462010M | 102d | 0d |  | MECH ENG [100 h]; MECH TECH [448 h] | 27,781.28 | BEVINS M | 1 | 1 | MIKE B | 11-028 |  |  | 12-035 |  |  |  |  |  |  |  |  |  |  |  |  |
| 13463030 |  | Install Septa & Dipoles MATL (Stands) |  | 43d | 2012-12-19 | 2013-02-27 | 13463025 | 102d | 78d |  | PROCUREMENT<$50K 60 | 10,262.31 | BEVINS M | 1 | 1 | MIKE B | 11-028 |  |  | 12-035 |  |  |  |  |  |  |  |  |  |  |  |  |
| 13463045 |  | Extraction - Install magnets and girders |  | 43d | 2012-12-19 | 2013-02-27 | 13463020, 13463035a, 13463025 | 102d | 78d |  | MECH TECH [1096 h]; MECH ENG [244 h] | 67,918.4 | BEVINS M | 1 | 1 | MIKE B | 11-028 |  |  | 12-035 |  |  |  |  |  |  |  |  |  |  |  |  |
| 13463050 |  | Extraction - Final align |  | 6d | 2013-06-19 | 2013-06-26 | 13463030, 13417120, 13463045 | 24d | 0d |  | MECH TECH [240 h]; MECH ENG [52 h] | 14,769.12 | BEVINS M | 1 | 1 | MIKE B | 11-028 |  |  | 12-035 |  |  |  |  |  |  |  |  |  |  |  |  |
| 13463055 |  | Re-Baseline Actuals Adjustment |  | 1d | 2013-08-30 | 2013-08-30 | 9-130M FS+227d | 20d |  |  | PROCUREMENT>$50K 69 NO ESCALATION | 256,305.09 | BEVINS M | 1 | 1 | MIKE B |  |  |  |  |  | 13-014 | ADJ |  |  |  |  |  |  |  |  |  |
| 23463035a |  | Extraction - Upstairs |  | 6d | 2013-09-03 | 2013-09-10 | 9-130M FS+228d | 44d | 42d | 8/5 M-F w/JLAB Holidays ReBaseline | MECH TECH [29.44 h]; MECH ENG [7.36 h] | 1,882.69 | BEVINS M | 1 | 1 | MIKE B | 11-028 |  |  | 12-035 |  |  |  |  |  | 12-053 | 23463035a | H | PE | 13-015 | PR |  |
| 23463045 |  | Extraction - Install magnets and girders |  | 15d | 2013-09-03 | 2013-09-23 | 9-130M FS+228d, 23463035a FS-48d | 2d | 0d | 8/5 M-F w/JLAB Holidays ReBaseline | MECH TECH [436.54 h]; MECH ENG [104.12 h] | 27,553.83 | BEVINS M | 1 | 1 | MIKE B | 11-028 |  |  | 12-035 |  |  |  |  |  |  | 23463045 | S | PE | 13-015 | PR |  |
| 23463050 |  | Extraction - Final align FY13 |  | 5d | 2013-09-24 | 2013-09-30 | 23463045, 23417120 FS-23d | 2d | 0d | 8/5 M-F w/JLAB Holidays ReBaseline | MECH TECH [100 h]; MECH ENG [25 h] | 6,395 | BEVINS M | 1 | 1 | MIKE B | 11-028 |  |  | 12-035 |  |  |  |  |  |  | 23463050 | S | PE | 13-015 | PR |  |
| 23463050a |  | Extraction - Final align FY14 |  | 7d | 2013-10-01 | 2013-10-09 | 23463050, 23417120 FS-23d, 23463045 | 2d |  | 8/5 M-F w/JLAB Holidays ReBaseline | MECH TECH [140 h]; MECH ENG [35 h] | 9,238.25 | BEVINS M | 1 | 1 | MIKE B | 11-028 |  |  | 12-035 |  |  |  |  |  |  | 23463050 | S | PE | 13-015 | PR | 14-001 |

Notes:
- 13462005: Explanation: IPL from 6 GeV 534213060 and / 534213120

| ID | WBS | Activity | Duration | Start | Finish | Predecessors | Total float | Free float | Resources | Cost | RESP - Responsibility | STRT%COMP for CM EVM | FNSH%COMP for CM EVM | CAM RESPONSIBLE | CR 08-058 | CR 11-028 | CR 12-053 | CR 13-014 | ReBaseline Actuals Adjustment |
| --- | --- | --- | --- | --- | --- | --- | --- | --- | --- | --- | --- | --- | --- | --- | --- | --- | --- | --- | --- |
|  | 4 | **1.3.4.6.4 NOT USED** |  |  |  |  |  |  |  |  |  |  |  |  |  |  |  |  |  |
|  | 5 | **1.3.4.6.5 NOT USED** |  |  |  |  |  |  |  |  |  |  |  |  |  |  |  |  |  |
|  | 6 | **1.3.4.6.6 NOT USED** |  |  |  |  |  |  |  |  |  |  |  |  |  |  |  |  |  |
|  | 7 | **1.3.4.6.7 NOT USED** |  |  |  |  |  |  |  |  |  |  |  |  |  |  |  |  |  |
|  | 5 | **1.3.5 EXTRACTION** |  | 2009-01-02 | 2013-08-30 |  |  |  |  |  |  |  |  |  |  |  |  |  |  |
|  | 1 | **1.3.5.1 CAVITIES** |  | 2009-01-02 | 2013-08-30 |  |  |  |  |  |  |  |  |  |  |  |  |  |  |
| 1351909LOE |  | FY09 Mngmnt Oversight (Cavities) | 189d | 2009-01-02 | 2009-09-30 | 1351909LOEX | 20d | 0d | SCIENTIST [423.73 h]; TRAVEL | 30,069.12 | SPATA M | 1 | 1 | MIKE S | 08-058 |  |  |  |  |
| 1351910LOE |  | FY10 Mngmnt Oversight (Cavities) | 248d | 2009-10-01 | 2010-09-30 | 1351909LOE | 20d | 0d | SCIENTIST [556 h]; TRAVEL | 40,714.11 | SPATA M | 1 | 1 | MIKE S |  |  |  |  |  |
| 1351018 |  | Fab fixturing Assys for Fab (Cavities) | 15d | 2010-10-01 | 2010-10-21 | 9-110M | 588d | 358d | MECH TECH [20 h] | 861.4 | SPATA M | 1 | 1 | MIKE S |  | 11-028 |  |  |  |
| 1351911LOE |  | FY11 Mngmnt Oversight (Cavities) | 248d | 2010-10-01 | 2011-09-30 | 1351910LOE | 20d | 0d | SCIENTIST [440 h] | 30,109.2 | SPATA M | 1 | 1 | MIKE S |  |  |  |  |  |
| 1351016 |  | Proc Separator Cavity Matls & subassemblies LABOR (Cavities) | 59d | 2011-12-01 | 2012-03-02 | 9-120M FS+41d, 12151020M | 230d | 0d | MECH TECH [20 h]; MECH ENG [48 h] | 4,254.56 | SPATA M | 1 | 1 | MIKE S |  | 11-028 |  |  |  |
| 1351016a |  | Proc Separator Cavity Matls & subassemblies MATERIALS (Cavities) | 59d | 2011-12-01 | 2012-03-02 | 1351016 FS-59d | 230d | 0d | PROCUREMENT<$50K 60 | 62,010.32 | SPATA M | 1 | 1 | MIKE S |  | 11-028 |  |  |  |
| 1351040 |  | Assy of Separator Cavities (Cavities) | 50d | 2012-04-09 | 2012-06-19 | 1351018, 1351016a FS+25d | 230d | 0d | MECH ENG [20 h]; MECH TECH [128 h]; PROCUREMENT<$50K 60 | 12,379.15 | SPATA M | 1 | 1 | MIKE S |  | 11-028 |  |  |  |
| 1351055 |  | Test Separator Cavities | 45d | 2012-06-20 | 2012-08-21 | 1351040 | 230d | 0d | ELEC TECH [40 h]; MECH TECH [32 h]; ELEC ENG [40 h] | 6,009.68 | SPATA M | 1 | 1 | MIKE S |  | 11-028 |  |  |  |
| 1351065 |  | Installtn of Separator Cavities (Cavities) FY12 | 17d | 2012-09-06 | 2012-09-28 | 2-02M, 1351055 FS+10d | 230d | 0d | ELEC TECH [68 h]; ELEC ENG [13.6 h]; MECH DES [27.2 h]; MECH TECH [68 h] | 8,292.6 | SPATA M | 1 | 1 | MIKE S |  | 11-028 | 12-053 |  |  |
| 1351065a |  | Installtn of Separator Cavities (Cavities) FY13 | 8d | 2012-10-01 | 2012-10-10 | 1351065 | 230d | 0d | ELEC TECH [32 h]; ELEC ENG [6.4 h]; MECH DES [12.8 h]; MECH TECH [32 h] | 4,027.07 | SPATA M | 1 | 1 | MIKE S |  | 11-028 | 12-053 |  |  |
| 1351080 |  | RF Characterization of Installed Separator Cavities (Cavities) | 10d | 2012-10-11 | 2012-10-24 | 1351065a | 230d | 0d | ELEC TECH [60 h]; ELEC ENG [60 h]; MECH ENG [12 h] | 7,969.32 | SPATA M | 1 | 1 | MIKE S |  | 11-028 |  |  |  |
| 1351950 |  | Re-Baseline Actuals Adjustment | 1d | 2013-08-30 | 2013-08-30 | 9-130M FS+227d | 20d |  | PROCUREMENT>$50K 69 NO ESCALATION | 88,708.49 | SPATA M | 1 | 1 | MIKE S |  |  |  | 13-014 | ADJ |
|  | 2 | **1.3.5.2 RF COMPONENTS** |  | 2012-01-05 | 2013-08-30 |  |  |  |  |  |  |  |  |  |  |  |  |  |  |
| 1352005 |  | Proc RF Components LABOR (RF Compnts) | 82d | 2012-01-05 | 2012-05-01 | 12156045, 9-120M FS+60d, 12152030M | 278d | 0d | ELEC DES [80 h]; ELEC ENG [40 h] | 6,863.2 | SPATA M | 1 | 1 | MIKE S |  | 11-028 |  |  |  |
| 1352005a |  | Proc RF Components MATERIAL (RF Compnts) | 82d | 2012-01-05 | 2012-05-01 | 1352005 FS-82d | 278d | 8d | PROCUREMENT<$50K 60 | 104,130.53 | SPATA M | 1 | 1 | MIKE S |  | 11-028 |  |  |  |
| 1352020 |  | Install RF Components (RF Compnts) | 46d | 2012-05-14 | 2012-07-18 | 1352005a, 2-02M | 270d | 0d | ELEC TECH [400 h]; MECH TECH [116 h] | 22,807.04 | SPATA M | 1 | 1 | MIKE S |  | 11-028 |  |  |  |
| 1352035 |  | Characterize Sys losses (RF Compnts) | 39d | 2012-07-19 | 2012-09-12 | 1352020 | 270d |  | ELEC TECH [200 h]; ELEC ENG [80 h] | 14,470.8 | SPATA M | 1 | 1 | MIKE S |  | 11-028 |  |  |  |
| 1352040 |  | Re-Baseline Actuals Adjustment | 1d | 2013-08-30 | 2013-08-30 | 9-130M FS+227d | 20d |  | PROCUREMENT>$50K 69 NO ESCALATION | 19,983.19 | SPATA M | 1 | 1 | MIKE S |  |  |  | 13-014 | ADJ |

| ID | WBS | Activity | Type | Duration | Start | Finish | Predecessors | Total float | Free float | Resources | Cost | RESP - Responsibility | STRT%COMP for CM EVM | FNSH%COMP for CM EVM | CAM RESPONSIBLE | CR 11-028 | CR 13-014 | ReBaseline Actuals Adjustment | CR 08-058 | CR 12-035 | CR 09-047 | CR 08-016 | CR 09-012 | CR 10-003 | CR 11-001 | CR 10-065 | Milestone Level |
| --- | --- | --- | --- | --- | --- | --- | --- | --- | --- | --- | --- | --- | --- | --- | --- | --- | --- | --- | --- | --- | --- | --- | --- | --- | --- | --- | --- |
|  | 3 | **1.3.5.3 RESONANCE CONTROL** |  |  | 2012-01-05 | 2013-08-30 |  |  |  |  |  |  |  |  |  |  |  |  |  |  |  |  |  |  |  |  |  |
| 1353005 |  | Procure Resonance Control LABOR (RESONANCE Control) |  | 61d | 2012-01-05 | 2012-04-02 | 9-120M FS+60d, 12153025M | 345d | 0d | ELEC ENG [48 h]; MECH ENG [32 h]; MECH DES [8 h]; MECH TECH [40 h]; ELEC TECH [20 h] | 8,676.28 | SPATA M | 1 | 1 | MIKE S | 11-028 |  |  |  |  |  |  |  |  |  |  |  |
| 1353005a |  | Procure Resonance Control MATERIAL (RESONANCE Control) |  | 61d | 2012-01-05 | 2012-04-02 | 1353005 FS-61d | 345d | 0d | PROCUREMENT<$50K 60 | 36,094.69 | SPATA M | 1 | 1 | MIKE S | 11-028 |  |  |  |  |  |  |  |  |  |  |  |
| 1353085 |  | Move 5th pass Controls/Rack (RESONANCE Control) |  | 30d | 2012-01-19 | 2012-03-01 | 4A-01M, 9-120M FS+69d | 396d | 166d | ELEC TECH [40 h]; MECH TECH [60 h] | 4,431.6 | SPATA M | 1 | 1 | MIKE S | 11-028 |  |  |  |  |  |  |  |  |  |  |  |
| 1353020 |  | Assemble Heater Units (RESONANCE Control) |  | 29d | 2012-04-03 | 2012-05-11 | 1353005a | 345d | 115d | MECH DES [12 h]; MECH TECH [140 h]; ELEC TECH [20 h] | 7,682.24 | SPATA M | 1 | 1 | MIKE S | 11-028 |  |  |  |  |  |  |  |  |  |  |  |
| 1353040 |  | Modify Control Chassis (RESONANCE Control) |  | 29d | 2012-04-03 | 2012-05-11 | 1353005a | 345d | 115d | COMP SCIENT [160 h] | 10,499.2 | SPATA M | 1 | 1 | MIKE S | 11-028 |  |  |  |  |  |  |  |  |  |  |  |
| 1353070 |  | Install Control Valves (RESONANCE Control) |  | 21d | 2012-04-03 | 2012-05-01 | 1353005a | 353d | 123d | MECH TECH [20 h]; ELEC TECH [20 h] | 1,771.4 | SPATA M | 1 | 1 | MIKE S | 11-028 |  |  |  |  |  |  |  |  |  |  |  |
| 1353095 |  | Sys Testing (RESONANCE Control) |  | 10d | 2012-10-25 | 2012-11-07 | 1353020, 1353040, 1353070, 1351080, 1353085 | 230d |  | MECH DES [20 h]; MECH TECH [60 h]; MECH ENG [60 h]; ELEC TECH [140 h]; ELEC ENG [112 h] | 22,617.72 | SPATA M | 1 | 1 | MIKE S | 11-028 |  |  |  |  |  |  |  |  |  |  |  |
| 1353100 |  | Re-Baseline Actuals Adjustment |  | 1d | 2013-08-30 | 2013-08-30 | 9-130M FS+227d | 20d |  | PROCUREMENT>$50K 69 NO ESCALATION | -38,313.59 | SPATA M | 1 | 1 | MIKE S |  | 13-014 | ADJ |  |  |  |  |  |  |  |  |  |
|  | 4 | **1.3.5.4 LAMBERTSON** |  |  | 2009-01-02 | 2013-08-30 |  |  |  |  |  |  |  |  |  |  |  |  |  |  |  |  |  |  |  |  |  |
| 1354909LOE |  | FY09 Engrng Oversight (LAMBERTSON) |  | 189d | 2009-01-02 | 2009-09-30 | 1354909LOEX | 148d | 0d | MECH ENG [60.97 h]; TRAVEL | 6,324.98 | SPATA M | 1 | 1 | MIKE S | 11-028 |  |  | 08-058 |  |  |  |  |  |  |  |  |
| 1354910LOE |  | FY10 Engrng Oversight (LAMBERTSON) |  | 248d | 2009-10-01 | 2010-09-30 | 1354909LOE | 148d | 0d | MECH ENG [80 h]; TRAVEL | 8,564.35 | SPATA M | 1 | 1 | MIKE S | 11-028 |  |  |  |  |  |  |  |  |  |  |  |
| 1354911LOE |  | FY11 Engrng Oversight (LAMBERTSON) |  | 120d | 2010-10-01 | 2011-03-31 | 1354910LOE | 148d | 128d | MECH ENG [38.71 h]; TRAVEL | 4,276.23 | SPATA M | 1 | 1 | MIKE S | 11-028 |  |  |  |  |  |  |  |  |  |  |  |
| 1354950 |  | Re-Baseline Actuals Adjustment |  | 1d | 2013-08-30 | 2013-08-30 | 9-130M FS+227d | 20d |  | PROCUREMENT>$50K 69 NO ESCALATION | -16,873.42 | SPATA M | 1 | 1 | MIKE S |  | 13-014 | ADJ |  |  |  |  |  |  |  |  |  |
|  | 5 | **1.3.5.5 CHICANE** |  |  | 2009-10-01 | 2013-08-30 |  |  |  |  |  |  |  |  |  |  |  |  |  |  |  |  |  |  |  |  |  |
| 1355910LOE |  | FY10 Mech Eng/Dsgner Oversight (CHICANE) |  | 248d | 2009-10-01 | 2010-09-30 | 1354909LOE | 148d | 0d | TRAVEL | 4,395.14 | SPATA M | 1 | 1 | MIKE S | 11-028 |  |  |  |  |  |  |  |  |  |  |  |
| 1355016 |  | Proc Septa Mag Iron & Coil Packs (CHICANE) |  | 65d | 2010-01-05 | 2010-04-07 | 12155050M, 9-100M FS+60d, 12156045 | 743d | 0d | MECH DES [60 h]; MECH ENG [80 h] | 7,982.4 | SPATA M | 1 | 1 | MIKE S |  |  |  |  | 12-035F |  |  |  |  |  |  |  |
| 1355030 |  | Proc Dipole Mag Iron & Coil Packs (CHICANE) |  | 65d | 2010-01-05 | 2010-04-07 | 12155050M, 9-100M FS+60d, 12156045 | 233d | 0d | MECH ENG [52 h]; MECH DES [52 h] | 5,776.68 | SPATA M | 1 | 1 | MIKE S |  |  |  |  | 12-035F |  |  |  |  |  |  |  |
| 1355018 |  | Insp Septa Matls (CHICANE) |  | 10d | 2010-04-08 | 2010-04-21 | 1355016, 13411087 | 743d | 467d | MECH ENG [4 h]; MECH TECH [20 h] | 1,098.2 | SPATA M | 1 | 1 | MIKE S |  |  |  |  | 12-035F | 09-047 |  |  |  |  |  |  |
| 1355035 |  | Insp Dipole Matls (CHICANE) |  | 10d | 2010-04-08 | 2010-04-21 | 1355030 | 233d | 0d | MECH ENG [4 h]; MECH TECH [20 h] | 1,098.2 | SPATA M | 1 | 1 | MIKE S |  |  |  |  | 12-035F |  |  |  |  |  |  |  |
| 1355040 |  | Fab Dipole Magnets (CHICANE) Original Labor FY10 |  | 113d | 2010-04-22 | 2010-09-30 | 1355035 | 233d | 0d | MECH DES [27.42 h]; MECH ENG [67.04 h] | 5,655.06 | SPATA M | 1 | 1 | MIKE S |  |  |  |  | 12-035F |  | 08-016 | 09-012 | 10-003 | 11-001 |  |  |
| 1355040a |  | Fab Dipole Magnets (CHICANE) Original Labor FY11 |  | 120d | 2010-10-01 | 2011-03-31 | 1355040 | 233d | 0d | MECH DES [29.13 h]; MECH ENG [71.19 h] | 6,197.15 | SPATA M | 1 | 1 | MIKE S | 11-028 |  |  |  | 12-035F |  | 08-016 | 09-012 | 10-003 | 11-001 |  |  |
| 1355911LOE |  | FY11 Mech Eng/Dsgner Oversight (CHICANE) |  | 120d | 2010-10-01 | 2011-03-31 | 1355910LOE | 148d | 128d | TRAVEL | 2,194.53 | SPATA M | 1 | 1 | MIKE S | 11-028 |  |  |  |  |  |  |  |  |  |  |  |
| 1355022 |  | Measure Septa Magnets (CHICANE) |  | 65d | 2011-12-01 | 2012-03-12 | 13411087D10 | 276d | 0d | MECH TECH [40 h]; MECH ENG [20 h] | 3,180 | SPATA M | 1 | 1 | MIKE S |  |  |  |  | 12-035F | 09-047 |  |  |  |  | 10-065 |  |
| 1355025M |  | Extraction Septas Ready for Installtn (CHICANE) | milestone | 0d | 2012-03-12 | 2012-03-12 | 1355018, 1355022 | 276d | 174d |  |  | SPATA M | 1 | 1 | MIKE S |  |  |  |  | 12-035F |  |  |  |  |  | 10-065 | 6 |
| 1355950 |  | Re-Baseline Actuals Adjustment |  | 1d | 2013-08-30 | 2013-08-30 | 9-130M FS+227d | 20d |  | PROCUREMENT>$50K 69 NO ESCALATION | -37,577.57 | SPATA M | 1 | 1 | MIKE S |  | 13-014 | ADJ |  |  |  |  |  |  |  |  |  |

| ID | WBS | Activity | Type | Duration | Start | Finish | Predecessors | Total float | Free float | Calendar | Resources | Cost | RESP - Responsibility | STRT%COMP for CM EVM | FNSH%COMP for CM EVM | CAM RESPONSIBLE | CR 11-028 | CR 12-035 | CR 13-014 | ReBaseline Actuals Adjustment | CR 08-058 | Advance Purchase Plan > 500K | CR 08-040 | CR 08-051 | 12 GEV MAJOR PROCUREMENT CATAGORY | CR 10-031 | CR 11-014 | CR 11-026 | CR 12-005 | CR 12-001 | CR 10-070 | CR 12-018 | CR 12-026 | CR 08-016 | CR 09-012 | Milestone Level | Original Activity ID Rebaseline | EVMS Reporting Codes | BOE Labor | CR 13-015 | Post Rebaseline | Over Under Fixed | BOE Procurement | Obligated Prior to Rebaseline | CR 14-001 |
| --- | --- | --- | --- | --- | --- | --- | --- | --- | --- | --- | --- | --- | --- | --- | --- | --- | --- | --- | --- | --- | --- | --- | --- | --- | --- | --- | --- | --- | --- | --- | --- | --- | --- | --- | --- | --- | --- | --- | --- | --- | --- | --- | --- | --- | --- |
|  | 6 | **1.3.5.6 STANDS** |  |  | 2009-10-01 | 2013-08-30 |  |  |  |  |  |  |  |  |  |  |  |  |  |  |  |  |  |  |  |  |  |  |  |  |  |  |  |  |  |  |  |  |  |  |  |  |  |  |  |
| 1356910LOE |  | FY10 Mech Eng/Dsgner Oversight (Stands) |  | 248d | 2009-10-01 | 2010-09-30 | 1354909LOE | 148d | 0d |  | TRAVEL | 2,197.58 | SPATA M | 1 | 1 | MIKE S | 11-028 |  |  |  |  |  |  |  |  |  |  |  |  |  |  |  |  |  |  |  |  |  |  |  |  |  |  |  |  |
| 1356911LOE |  | FY11 Mech Eng/Dsgner Oversight (Stands) |  | 120d | 2010-10-01 | 2011-03-31 | 1356910LOE | 148d | 128d |  | TRAVEL | 1,097.26 | SPATA M | 1 | 1 | MIKE S | 11-028 |  |  |  |  |  |  |  |  |  |  |  |  |  |  |  |  |  |  |  |  |  |  |  |  |  |  |  |  |
| 1356018 |  | Proc Stands Matls (Stands) |  | 64d | 2010-12-07 | 2011-03-16 | 12156040M, 9-110M FS+45d, 12156045, 12156002 | 430d | 0d |  | MECH ENG [100 h]; MECH DES [8 h]; PROCUREMENT<$50K 60 | 19,980.79 | SPATA M | 1 | 1 | MIKE S | 11-028 | 12-035F |  |  |  |  |  |  |  |  |  |  |  |  |  |  |  |  |  |  |  |  |  |  |  |  |  |  |  |
| 1356020 |  | Insp Matls (Stands) |  | 11d | 2011-03-17 | 2011-03-31 | 1356018 | 430d | 257d |  | MECH ENG [6.6 h]; MECH TECH [22 h] | 1,396.01 | SPATA M | 1 | 1 | MIKE S | 11-028 | 12-035F |  |  |  |  |  |  |  |  |  |  |  |  |  |  |  |  |  |  |  |  |  |  |  |  |  |  |  |
| 1356950 |  | Re-Baseline Actuals Adjustment |  | 1d | 2013-08-30 | 2013-08-30 | 9-130M FS+227d | 20d |  |  | PROCUREMENT>$50K 69 NO ESCALATION | 170.96 | SPATA M | 1 | 1 | MIKE S |  |  | 13-014 | ADJ |  |  |  |  |  |  |  |  |  |  |  |  |  |  |  |  |  |  |  |  |  |  |  |  |  |
|  | 6 | **1.3.6 INSTRUMENTATION/CONTROLS/SAFETY SYS** |  |  | 2009-01-02 | 2014-10-31 |  |  |  |  |  |  |  |  |  |  |  |  |  |  |  |  |  |  |  |  |  |  |  |  |  |  |  |  |  |  |  |  |  |  |  |  |  |  |  |
|  | 1 | **1.3.6.1 BEAM DIAGNOSTICS** |  |  | 2009-01-02 | 2014-10-31 |  |  |  |  |  |  |  |  |  |  |  |  |  |  |  |  |  |  |  |  |  |  |  |  |  |  |  |  |  |  |  |  |  |  |  |  |  |  |  |
|  | 1 | **1.3.6.1.1 BPM'S** |  |  | 2009-01-02 | 2014-10-31 |  |  |  |  |  |  |  |  |  |  |  |  |  |  |  |  |  |  |  |  |  |  |  |  |  |  |  |  |  |  |  |  |  |  |  |  |  |  |  |
| 13611909LOE |  | FY09 Mngmnt Effort for BPMs |  | 189d | 2009-01-02 | 2009-09-30 | 13611909LOEX | 20d | 0d |  | SR STAFF [6.1 h] | 627.32 | GARZA O | 1 | 1 | MIKE S |  |  |  |  | 08-058 |  |  |  |  |  |  |  |  |  |  |  |  |  |  |  |  |  |  |  |  |  |  |  |  |
| 13611910LOE |  | FY10 Mngmnt Effort for BPMs |  | 248d | 2009-10-01 | 2010-09-30 | 13611909LOE | 20d | 0d |  | SR STAFF [8 h] | 848.96 | GARZA O | 1 | 1 | MIKE S |  |  |  |  |  |  |  |  |  |  |  |  |  |  |  |  |  |  |  |  |  |  |  |  |  |  |  |  |  |
| 13611911LOE |  | FY11 Mngmnt Effort for BPMs |  | 248d | 2010-10-01 | 2011-09-30 | 13611910LOE | 20d | 0d |  | SR STAFF [88 h] | 9,636.88 | GARZA O | 1 | 1 | MIKE S |  |  |  |  |  |  |  |  |  |  |  |  |  |  |  |  |  |  |  |  |  |  |  |  |  |  |  |  |  |
| 13611014 |  | Labor - SEE BPMs CANS Accelerator |  | 40d | 2010-11-05 | 2011-01-11 | 9-110M FS+25d, 121611055M | 557d | 6d |  | ELEC ENG [12 h]; ELEC TECH [16 h] | 1,504.88 | GARZA O | 1 | 1 | MIKE S |  |  |  |  |  | APP | 08-040 | 08-051 | 3611A | 10-031 | 11-014 | 11-026 | 12-005 |  |  |  |  |  |  |  |  |  |  |  |  |  |  |  |  |
| 13611014A |  | Prcrmnt - SEE BPMs CANS Accelerator |  | 121d | 2010-12-01 | 2011-05-31 | 9-110M FS+41d, 13611014 FS-30d | 551d | 0d |  | PROCUREMENT<$50K 60 | 155,018 | GARZA O | 1 | 1 | MIKE S |  |  |  |  |  | APP |  |  | 3611A | 10-031 | 11-014 | 11-026 | 12-005 |  |  |  |  |  |  |  |  |  |  |  |  |  |  |  |  |
| 13611014Aa |  | Testing - SEE BPM Compnts CANS Accelerator |  | 66d | 2011-03-01 | 2011-06-01 | 13611014A FS-65d | 551d | 531d |  | COMP SCIENT [24 h]; ELEC ENG [24 h]; ELEC TECH [68 h] | 6,075.64 | GARZA O | 1 | 1 | MIKE S |  |  |  |  |  | APP |  |  | 3611A |  | 11-014 | 11-026 | 12-005 |  |  |  |  |  |  |  |  |  |  |  |  |  |  |  |  |
| 13611014Ab |  | Labor - SEE BPMs CANS Hall D |  | 10d | 2011-05-02 | 2011-05-13 | 9-110M FS+141d | 465d | 0d |  | ELEC TECH [16 h]; ELEC ENG [12 h] | 1,504.88 | GARZA O | 1 | 1 | MIKE S |  |  |  |  |  | APP |  |  | 3611A |  | 11-014 | 11-026 | 12-005 |  |  |  |  |  |  |  |  |  |  |  |  |  |  |  |  |
| 13611014Ac |  | Prcrmnt - SEE BPMs CANS Hall D |  | 107d | 2011-05-02 | 2011-09-30 | 13611014Ab FS-10d | 465d | 0d |  | PROCUREMENT<$50K 60 | 72,000 | GARZA O | 1 | 1 | MIKE S |  |  |  |  |  | APP |  |  | 3611A |  | 11-014 | 11-026 | 12-005 |  |  |  |  |  |  |  |  |  |  |  |  |  |  |  |  |
| 13611014Ad |  | Testing - SEE BPM Compnts CANS Hall D FY11 |  | 75d | 2011-06-16 | 2011-09-30 | 13611014Ac FS-75d | 465d | 0d |  | ELEC ENG [15.79 h]; ELEC TECH [67.11 h] | 3,950.01 | GARZA O | 1 | 1 | MIKE S |  |  |  |  |  | APP |  |  | 3611A |  | 11-014 | 11-026 | 12-005 | 12-001 |  |  |  |  |  |  |  |  |  |  |  |  |  |  |  |
| 13611014Ada |  | Testing - SEE BPM Compnts CANS Hall D FY12 |  | 1d | 2011-10-03 | 2011-10-03 | 13611014Ad | 465d | 445d |  | ELEC ENG [0.21 h]; ELEC TECH [0.89 h] | 54.1 | GARZA O | 1 | 1 | MIKE S |  |  |  |  |  | APP |  |  | 3611A |  | 11-014 | 11-026 | 12-005 | 12-001 |  |  |  |  |  |  |  |  |  |  |  |  |  |  |  |
| 13611912LOE |  | FY12 Mngmnt Effort for BPMs |  | 247d | 2011-10-03 | 2012-09-28 | 13611911LOE | 20d | 0d |  | SR STAFF [88 h] | 9,944 | GARZA O | 1 | 1 | MIKE S |  |  |  |  |  |  |  |  |  |  |  |  |  |  |  |  |  |  |  |  |  |  |  |  |  |  |  |  |  |
| 13611026 |  | Labor - West ARC Completion BPMs |  | 140d | 2012-01-05 | 2012-07-24 | 9-120M FS+60d | 279d | 0d |  | ELEC TECH [1120 h] | 49,425.6 | GARZA O | 1 | 1 | MIKE S |  | 12-035F |  |  |  |  |  |  |  | 10-031 |  | 11-026 | 12-005 |  | 10-070 | 12-018F |  |  |  |  |  |  |  |  |  |  |  |  |  |
| 13611026a |  | Procurement - West ARC Completion BPMs |  | 5d | 2012-01-05 | 2012-01-11 | 13611026 FS-140d | 404d | 125d |  | PROCUREMENT<$50K 60 | 8,000 | GARZA O | 1 | 1 | MIKE S |  | 12-035F |  |  |  |  |  |  |  | 10-031 |  | 11-026 | 12-005 |  | 10-070 | 12-018F |  |  |  |  |  |  |  |  |  |  |  |  |  |
| 13611014Af |  | RF Receiver - First Article Unit SEE BPM |  | 49d | 2012-02-01 | 2012-04-10 | 9-120M FS+78d | 172d | 0d |  | ELEC ENG [392 h] | 27,659.52 | GARZA O | 1 | 1 | MIKE S |  |  |  |  |  |  |  |  |  |  |  |  | 12-005 |  |  |  | 12-026F |  |  |  |  |  |  |  |  |  |  |  |  |
| 13611014Ag |  | Digital IF - First Article Unit SEE BPM |  | 49d | 2012-02-01 | 2012-04-10 | 9-120M FS+78d | 172d | 0d |  | ELEC ENG [392 h] | 27,659.52 | GARZA O | 1 | 1 | MIKE S |  |  |  |  |  |  |  |  |  |  |  |  | 12-005 |  |  |  | 12-026F |  |  |  |  |  |  |  |  |  |  |  |  |
| 13611065 |  | System Documentation - BPMs First Article |  | 80d | 2012-02-01 | 2012-05-23 | 13611014Af FS-49d | 322d | 289d |  | ELEC DES [496 h] | 25,052.96 | GARZA O | 1 | 1 | MIKE S |  |  |  |  |  |  |  |  |  | 10-031 |  |  | 12-005 |  | 10-070 |  | 12-026 |  |  |  |  |  |  |  |  |  |  |  |  |
| 13611014Ah |  | RF Receiver Enclosure - First Article Unit SEE BPM |  | 68d | 2012-04-11 | 2012-07-17 | 13611014Af, 13611014Ag | 172d | 0d |  | ELEC ENG [544 h]; ELEC TECH [544 h] | 62,391.36 | GARZA O | 1 | 1 | MIKE S |  |  |  |  |  |  |  |  |  |  |  |  | 12-005 |  |  |  | 12-026F |  |  |  |  |  |  |  |  |  |  |  |  |
| 13611025b |  | System Installation Software Support First Article - Electronics SEE BPMs |  | 40d | 2012-06-06 | 2012-07-31 | 13611014Ah FS-30d | 281d | 261d |  | COMP SCIENT [320 h] | 20,998.4 | GARZA O | 1 | 1 | MIKE S |  |  |  |  |  |  |  |  |  |  |  |  | 12-005 |  |  |  |  |  |  |  |  |  |  |  |  |  |  |  |  |
| 13611026b |  | Hook-up & Check-out Arc 10 BPMs |  | 15d | 2012-07-11 | 2012-07-31 | 13611026 FS-10d, 13611026a | 279d |  |  | COMP SCIENT [80 h]; ELEC TECH [80 h] | 8,780 | GARZA O | 1 | 1 | MIKE S |  | 12-035F |  |  |  |  |  |  |  | 10-031 |  | 11-026 | 12-005 |  | 10-070 | 12-018F |  |  |  |  |  |  |  |  |  |  |  |  |  |
| 13611913LOE |  | FY13 Mngmnt Effort for BPMs |  | 228d | 2012-10-01 | 2013-08-30 | 13611912LOE | 20d |  |  | SR STAFF [80.9 h] | 9,432.94 | GARZA O | 1 | 1 | MIKE S |  |  | 13-014 |  |  |  |  |  |  |  |  |  |  |  |  |  |  |  |  |  |  |  |  |  |  |  |  |  |  |
| 13611014B |  | Procurement Labor - SEE BPMs ELECTRONICS |  | 56d | 2013-02-01 | 2013-04-22 | 9-130M FS+80d | 20d | 0d |  | ELEC ENG [240 h]; ELEC TECH [240 h] | 28,404 | GARZA O | 1 | 1 | MIKE S |  |  |  |  |  | APP |  |  | 3611A | 10-031 |  | 11-026 | 12-005 |  | 10-070 |  | 12-026 |  |  |  |  |  |  |  |  |  |  |  |  |
| 13611014C |  | Prcrmnt - SEE BPMs ELECTRONICS |  | 117d | 2013-02-01 | 2013-07-18 | 9-130M FS+80d | 27d | 7d |  | PROCUREMENT<$50K 60 | 175,423 | GARZA O | 1 | 1 | MIKE S |  |  |  |  |  | APP |  |  | 3611A | 10-031 |  | 11-026 | 12-005 |  | 10-070 |  | 12-026 |  |  |  |  |  |  |  |  |  |  |  |  |
| 13611036 |  | First Article Cavities - nA BPM Sys |  | 58d | 2013-02-01 | 2013-04-24 | 9-130M FS+80d | 75d | 0d |  | ELEC ENG [464 h]; MECH TECH [240 h] | 44,790.24 | GARZA O | 1 | 1 | MIKE S |  |  |  |  |  |  |  |  |  |  |  |  | 12-005 |  |  |  | 12-026 |  |  |  |  |  |  |  |  |  |  |  |  |
| 13611038 |  | First Article Unit RF Receiver - nA BPM Sys |  | 68d | 2013-02-01 | 2013-05-08 | 9-130M FS+80d | 66d | 0d |  | ELEC ENG [400 h] | 29,124 | GARZA O | 1 | 1 | MIKE S |  |  |  |  |  |  |  |  |  |  |  |  | 12-005 |  |  |  | 12-026 |  |  |  |  |  |  |  |  |  |  |  |  |
| 13611038a |  | First Article Unit Digital IF - nA BPM Sys |  | 48d | 2013-02-01 | 2013-04-10 | 9-130M FS+80d | 86d | 20d |  | ELEC ENG [320 h] | 23,299.2 | GARZA O | 1 | 1 | MIKE S |  |  |  |  |  |  |  |  |  |  |  |  | 12-005 |  |  |  | 12-026 |  |  |  |  |  |  |  |  |  |  |  |  |
| 13611039 |  | Procurement Labor Electronics - nA BPM Sys |  | 38d | 2013-02-01 | 2013-03-27 | 9-130M FS+80d | 33d | 0d |  | ELEC TECH [304 h]; ELEC ENG [120 h] | 22,581.36 | GARZA O | 1 | 1 | MIKE S |  |  |  |  |  |  |  |  |  |  |  |  | 12-005 |  |  |  | 12-026 |  |  |  |  |  |  |  |  |  |  |  |  |
| 13611040 |  | Procurements Electronics - nA BPM Sys |  | 38d | 2013-02-01 | 2013-03-27 | 13611039 FS-38d, 121611055M | 33d | 0d |  | PROCUREMENT<$50K 60 | 40,760.05 | GARZA O | 1 | 1 | MIKE S |  |  |  |  |  | APP |  |  |  |  |  |  | 12-005 |  | 10-070 |  | 12-026 |  |  |  |  |  |  |  |  |  |  |  |  |
| 13611065a |  | System Documentation - BPMs |  | 145d | 2013-02-01 | 2013-08-27 | 9-130M FS+80d | 33d | 0d |  | ELEC DES [744 h] | 38,777.28 | GARZA O | 1 | 1 | MIKE S |  |  |  |  |  |  |  |  |  | 10-031 |  |  | 12-005 |  | 10-070 |  | 12-026 |  |  |  |  |  |  |  |  |  |  |  |  |
| 13611070 |  | First Article Unit - Power Supply SEE BPMs |  | 54d | 2013-03-04 | 2013-05-16 | 13611014Ah, 9-130M FS+100d | 20d | 0d |  | ELEC ENG [240 h]; ELEC TECH [240 h] | 28,404 | GARZA O | 1 | 1 | MIKE S |  |  |  |  |  |  |  |  |  |  |  |  | 12-005 |  |  |  | 12-026 |  |  |  |  |  |  |  |  |  |  |  |  |
| 13611075 |  | Procurement Labor - Power Supply SEE BPMs |  | 60d | 2013-03-04 | 2013-05-24 | 13611070 FS-54d | 20d | 0d |  | ELEC TECH [200 h] | 9,108 | GARZA O | 1 | 1 | MIKE S |  |  |  |  |  |  |  |  |  |  |  |  | 12-005 |  |  |  | 12-026 |  |  |  |  |  |  |  |  |  |  |  |  |
| 13611080 |  | Procurement - Power Supply SEE BPMs |  | 60d | 2013-03-04 | 2013-05-24 | 13611075 FS-60d | 20d | 0d |  | PROCUREMENT<$50K 60 | 30,441.05 | GARZA O | 1 | 1 | MIKE S |  |  |  |  |  |  |  |  |  |  |  |  | 12-005 |  |  |  | 12-026 |  |  |  |  |  |  |  |  |  |  |  |  |
| 13611045 |  | Assembly Electronics Labor - nA BPM Sys |  | 83d | 2013-03-27 | 2013-07-23 | 13611040 FS-1d | 33d | 0d |  | ELEC TECH [400 h]; ELEC ENG [80 h] | 24,040.8 | GARZA O | 1 | 1 | MIKE S |  |  |  |  |  | APP |  |  |  |  |  |  | 12-005 |  | 10-070 |  | 12-026 |  |  |  |  |  |  |  |  |  |  |  |  |
| 13611050 |  | Assembly & Testing Procurement - nA BPM Sys |  | 83d | 2013-03-27 | 2013-07-23 | 13611040 FS-1d, 13611045 FS-83d | 33d | 0d |  | PROCUREMENT<$50K 60 | 8,255.2 | GARZA O | 1 | 1 | MIKE S |  |  |  |  |  |  |  |  |  |  |  |  | 12-005 |  | 10-070 |  | 12-026 |  |  |  |  |  |  |  |  |  |  |  |  |
| 13611015A |  | Labor - Fab & Assy - SEE BPMs ELECTRONICS |  | 83d | 2013-04-23 | 2013-08-19 | 13611014B, 13611014C FS-68d | 20d | 0d |  | ELEC ENG [664 h]; ELEC TECH [664 h] | 78,584.4 | GARZA O | 1 | 1 | MIKE S |  |  |  |  |  | APP |  |  |  | 10-031 |  | 11-026 | 12-005 |  | 10-070 |  | 12-026 |  |  |  |  |  |  |  |  |  |  |  |  |
| 13611015B |  | Procrmnt - Fab/Assy & Testing - SEE BPMs ELECTRONICS |  | 83d | 2013-04-23 | 2013-08-19 | 13611015A FS-83d, 13611014C FS-68d, 13611014B | 20d | 0d |  | PROCUREMENT<$50K 60 | 77,392.5 | GARZA O | 1 | 1 | MIKE S |  |  |  |  |  | APP |  |  |  | 10-031 |  | 11-026 | 12-005 |  | 10-070 |  | 12-026 |  |  |  |  |  |  |  |  |  |  |  |  |
| 13611037 |  | Procurement Labor Cavities - nA BPM Sys |  | 20d | 2013-04-25 | 2013-05-22 | 13611036 | 75d | 0d |  | ELEC TECH [80 h]; MECH TECH [80 h] | 7,312 | GARZA O | 1 | 1 | MIKE S |  |  |  |  |  |  |  |  |  |  |  |  | 12-005 |  |  |  | 12-026 |  |  |  |  |  |  |  |  |  |  |  |  |
| 13611037a |  | Procurement Cavities - nA BPM Sys |  | 20d | 2013-04-25 | 2013-05-22 | 13611037 FS-20d, 13611036 FS-1d | 75d | 42d |  | PROCUREMENT<$50K 60 | 136,210.8 | GARZA O | 1 | 1 | MIKE S |  |  |  |  |  |  |  |  |  |  |  |  | 12-005 |  |  |  | 12-026 |  |  |  |  |  |  |  |  |  |  |  |  |
| 13611060 |  | Software support - nA BPMs |  | 80d | 2013-05-06 | 2013-08-27 | 13611055 FS-80d, 13611050 FS-60d | 33d | 0d |  | COMP SCIENT [640 h] | 43,334.4 | GARZA O | 1 | 1 | MIKE S |  |  |  |  |  |  |  |  |  | 10-031 |  |  | 12-005 |  | 10-070 |  | 12-026 |  |  |  |  |  |  |  |  |  |  |  |  |
| 13611038b |  | First Article Enclosure nA Receiver - nA BPM Sys |  | 19d | 2013-05-09 | 2013-06-05 | 13611038a, 13611038 | 66d | 33d |  | ELEC ENG [80 h]; ELEC TECH [152 h] | 12,746.88 | GARZA O | 1 | 1 | MIKE S |  |  |  |  |  |  |  |  |  |  |  |  | 12-005 |  |  |  | 12-026 |  |  |  |  |  |  |  |  |  |  |  |  |
| 13611085 |  | Assembly Labor - Power Supply SEE BPMs |  | 68d | 2013-05-28 | 2013-08-30 | 13611080, 13611075 | 20d |  |  | ELEC TECH [544 h] | 24,773.76 | GARZA O | 1 | 1 | MIKE S |  |  | 13-014 |  |  |  |  |  |  |  |  |  | 12-005 |  |  |  | 12-026 |  |  |  |  |  |  |  |  |  |  |  |  |
| 13611025 |  | System Installation - Electronics SEE BPMs |  | 29d | 2013-07-23 | 2013-08-30 | 13611015B FS-20d, 13611014Aa, 1362025 FS-115d, 13611014Ada | 20d |  |  | ELEC TECH [232 h] | 10,565.28 | GARZA O | 1 | 1 | MIKE S |  |  | 13-014 |  |  | APP | 08-040 | 08-051 |  | 10-031 |  | 11-026 | 12-005 |  | 10-070 |  | 12-026 | 08-016 | 09-012 |  |  |  |  |  |  |  |  |  |  |
| 13611055 |  | System Installation Electronics - nA BPM Sytem (BPM) |  | 25d | 2013-07-24 | 2013-08-27 | 13611038b, 13611065, 13611050, 13611037a, 1362025 | 33d | 0d |  | ELEC TECH [200 h] | 9,108 | GARZA O | 1 | 1 | MIKE S |  |  |  |  |  | APP |  |  |  | 10-031 |  |  | 12-005 |  | 10-070 |  | 12-026 | 08-016 | 09-012 |  |  |  |  |  |  |  |  |  |  |
| 13611055a |  | System Installation Electronics Contract Labor - nA BPM Sytem (BPM) |  | 25d | 2013-07-24 | 2013-08-27 | 13611065, 13611038b, 13611055 FS-25d, 13611037a | 33d | 0d |  | PROCUREMENT<$50K 60 | 16,510.4 | GARZA O | 1 | 1 | MIKE S |  |  |  |  |  | APP |  |  |  |  |  |  | 12-005 |  |  |  | 12-026 |  |  |  |  |  |  |  |  |  |  |  |  |
| 13611025c |  | System Installation Software Support - Electronics SEE BPMs |  | 9d | 2013-08-20 | 2013-08-30 | 13611014Ag, 13611025b, 13611015B | 20d |  |  | COMP SCIENT [72 h] | 4,875.12 | GARZA O | 1 | 1 | MIKE S |  |  | 13-014 |  |  |  |  |  |  |  |  |  | 12-005 |  |  |  | 12-026 |  |  |  |  |  |  |  |  |  |  |  |  |
| 13611065M |  | nA BPMs Comp | milestone | 0d | 2013-08-27 | 2013-08-27 | 13611065a, 13611055a, 13611060 | 33d |  |  |  |  | GARZA O | 1 | 1 | MIKE S |  |  |  |  |  |  |  |  |  | 10-031 |  |  | 12-005 |  | 10-070 |  | 12-026 |  |  | 6 |  |  |  |  |  |  |  |  |  |
| 13611950 |  | Re-Baseline Actuals Adjustment |  | 1d | 2013-08-30 | 2013-08-30 | 9-130M FS+227d | 20d |  |  | PROCUREMENT>$50K 69 NO ESCALATION | -187,365.47 | GARZA O | 1 | 1 | MIKE S |  |  | 13-014 | ADJ |  |  |  |  |  |  |  |  |  |  |  |  |  |  |  |  |  |  |  |  |  |  |  |  |  |
| 23611014B |  | Procurement Labor - SPM BPMs ELECTRONICS FY13 |  | 20d | 2013-09-03 | 2013-09-30 | 9-130M FS+228d | 43.5d | 0d | 8/5 M-F w/JLAB Holidays ReBaseline | ELEC ENG [25.82 h]; ELEC TECH [25.82 h] | 3,055.21 | GARZA O | 1 | 1 | MIKE S |  |  |  |  |  | APP |  |  | 3611A | 10-031 |  | 11-026 | 12-005 |  | 10-070 |  | 12-026 |  |  |  | 23611014B | H | PE | 13-015 | PR |  |  |  |  |
| 23611014D5 |  | Prcrmnt - SPM BPMs ELECTRONICS (Previously Obligated) |  | 43d | 2013-09-03 | 2013-10-31 | 9-130M FS+228d | 44d | 20d | 8/5 M-F w/JLAB Holidays ReBaseline | PROCUREMENT<$50K 60 NO ESCALATION FY14 | 13,621.42 | GARZA O | 1 | 1 | MIKE S |  |  |  |  |  | APP |  |  | 3611A | 10-031 |  | 11-026 | 12-005 |  | 10-070 |  | 12-026 |  |  |  | 23611014D | D |  | 13-015 | PR | y | PE | OB |  |
| 23611026b |  | Hook-up & Check-out Arc 10 BPMs |  | 20d | 2013-09-03 | 2013-09-30 | 9-130M FS+228d | 4d |  | 8/5 M-F w/JLAB Holidays ReBaseline | COMP SCIENT [56 h]; ELEC TECH [56 h] | 6,342 | GARZA O | 1 | 1 | MIKE S |  | 12-035F |  |  |  |  |  |  |  | 10-031 |  | 11-026 | 12-005 |  | 10-070 | 12-018F |  |  |  |  | 23611026b | H | PE | 13-015 | PR |  |  |  |  |
| 23611065a |  | System Documentation - BPMs FY13 |  | 20d | 2013-09-03 | 2013-09-30 | 9-130M FS+228d | 262d | 0d | 8/5 M-F w/JLAB Holidays ReBaseline | ELEC DES [55 h] | 2,866.6 | GARZA O | 1 | 1 | MIKE S |  |  |  |  |  |  |  |  |  | 10-031 |  |  | 12-005 |  | 10-070 |  | 12-026 |  |  |  | 23611065a |  | PE | 13-015 | PR |  |  |  |  |
| 23611070 |  | First Article Unit - Power Supplies/PC104/Timing Modules SPM BPMs |  | 10d | 2013-09-03 | 2013-09-16 | 9-130M FS+228d | 50d | 0d | 8/5 M-F w/JLAB Holidays ReBaseline | ELEC ENG [60 h]; ELEC TECH [60 h] | 7,101 | GARZA O | 1 | 1 | MIKE S |  |  |  |  |  |  |  |  |  |  |  |  | 12-005 |  |  |  | 12-026 |  |  |  | 23611070 |  | PE | 13-015 | PR |  |  |  |  |
| 23611075 |  | Procurement Labor - Power Supplies/PC104/Timing Modules SPM BPMs FY13 |  | 20d | 2013-09-03 | 2013-09-30 | 23611070 FS-10d | 50d | 0d | 8/5 M-F w/JLAB Holidays ReBaseline | ELEC TECH [32.26 h] | 1,469.12 | GARZA O | 1 | 1 | MIKE S |  |  |  |  |  |  |  |  |  |  |  |  | 12-005 |  |  |  | 12-026 |  |  |  | 23611075 |  | PE | 13-015 | PR |  |  |  |  |
| 23611913LOE |  | FY13 Mngmnt Effort for BPMs |  | 20d | 2013-09-03 | 2013-09-30 | 9-130M FS+228d | 67d | 0d | 8/5 M-F w/JLAB Holidays ReBaseline | SCIENTIST [10.73 h] | 781.79 | GARZA O | 1 | 1 | MIKE S |  |  |  |  |  |  |  |  |  |  |  |  |  |  |  |  |  |  |  |  | 23611913LOE | E | PE | 13-015 | PR |  |  |  |  |
| 23611014Ba |  | Procurement Labor - SPM BPMs ELECTRONICS FY14 |  | 23.5d | 2013-10-01 | 2013-11-01 | 23611014B, 9-130M FS+228d | 43.5d | 19.5d | 8/5 M-F w/JLAB Holidays ReBaseline | ELEC ENG [29.68 h]; ELEC TECH [29.68 h] | 3,625.13 | GARZA O | 1 | 1 | MIKE S |  |  |  |  |  | APP |  |  | 3611A | 10-031 |  | 11-026 | 12-005 |  | 10-070 |  | 12-026 |  |  |  | 23611014B | H | PE | 13-015 | PR |  |  |  | 14-001 |
| 23611014D |  | Prcrmnt - SPM BPMs ELECTRONICS |  | 43d | 2013-10-01 | 2013-12-02 | 9-140M | 24d | 0d | 8/5 M-F w/JLAB Holidays ReBaseline | PROCUREMENT<$50K 60 | 36,269.15 | GARZA O | 1 | 1 | MIKE S |  |  |  |  |  | APP |  |  | 3611A | 10-031 |  | 11-026 | 12-005 |  | 10-070 |  | 12-026 |  |  |  | 23611014D | D |  | 13-015 | PR |  | PE |  | 14-001 |
| 23611015A |  | Labor - Fab & Assy - SEE BPMs ELECTRONICS |  | 77d | 2013-10-01 | 2014-01-30 | 23611014Ba FS-43d, 23611014D FS-43d, 23611014D5 FS-43d, 23611014B FS-43d | 53d | 29d | 8/5 M-F w/JLAB Holidays ReBaseline | ELEC ENG [398.4 h]; ELEC TECH [398.4 h] | 48,652.61 | GARZA O | 1 | 1 | MIKE S |  |  |  |  |  | APP |  |  |  | 10-031 |  | 11-026 | 12-005 |  | 10-070 |  | 12-026 |  |  |  | 23611015A |  | PE | 13-015 | PR |  |  |  | 14-001 |
| 23611065aa |  | System Documentation - BPMs FY14 |  | 28d | 2013-10-01 | 2013-11-07 | 9-130M FS+228d, 23611065a | 262d | 242d | 8/5 M-F w/JLAB Holidays ReBaseline | ELEC DES [77 h] | 4,141.06 | GARZA O | 1 | 1 | MIKE S |  |  |  |  |  |  |  |  |  | 10-031 |  |  | 12-005 |  | 10-070 |  | 12-026 |  |  |  | 23611065a |  | PE | 13-015 | PR |  |  |  | 14-001 |
| 23611075a |  | Procurement Labor - Power Supplies/PC104/Timing Modules SPM BPMs FY14 |  | 42d | 2013-10-01 | 2013-11-27 | 23611075, 23611070 FS-10d | 50d | 0d | 8/5 M-F w/JLAB Holidays ReBaseline | ELEC TECH [67.75 h] | 3,183.57 | GARZA O | 1 | 1 | MIKE S |  |  |  |  |  |  |  |  |  |  |  |  | 12-005 |  |  |  | 12-026 |  |  |  | 23611075 |  | PE | 13-015 | PR |  |  |  | 14-001 |
| 23611914LOE |  | FY14 Mngmnt Effort for BPMs Part A |  | 42d | 2013-10-01 | 2013-11-27 | 23611913LOE | 67d | 0d | 8/5 M-F w/JLAB Holidays ReBaseline | SCIENTIST [15.07 h] | 1,132.96 | GARZA O | 1 | 1 | MIKE S |  |  |  |  |  |  |  |  |  |  |  |  |  |  |  |  |  |  |  |  | 23611914LOE | E | PE | 13-015 | PR |  |  |  | 14-001 |
| 23611080 |  | Procurement - Power Supplies/PC104/Timing Modules SPM BPMs |  | 62d | 2013-10-03 | 2014-01-10 | 23611075 FS-40d, 23611075a FS-40d | 50d | 0d | 8/5 M-F w/JLAB Holidays ReBaseline | PROCUREMENT<$50K 60 | 20,889.06 | GARZA O | 1 | 1 | MIKE S |  |  |  |  |  |  |  |  |  |  |  |  | 12-005 |  |  |  | 12-026 |  |  |  | 23611080 |  |  | 13-015 | PR |  | EV |  | 14-001 |
| 23611085 |  | Assembly Labor - Power Supplies/PC104/Timing Modules SPM BPMs Part A |  | 40d | 2013-10-03 | 2013-11-27 | 23611075 FS-62d, 23611080 FS-62d, 23611075a FS-62d | 50d | 0d | 8/5 M-F w/JLAB Holidays ReBaseline | ELEC TECH [332.47 h] | 15,622.77 | GARZA O | 1 | 1 | MIKE S |  |  |  |  |  |  |  |  |  |  |  |  | 12-005 |  |  |  | 12-026 |  |  |  | 23611085 |  | PE | 13-015 | PR |  |  |  | 14-001 |

Notes:
- 1356018: Corrective Actions: Add pred to Mark's procurement / Stands
- 13611026: Entry Criteria: Ext Pred: Girders, beamline, / IOCs, network installed
- 13611026a: Entry Criteria: Ext Pred: Girders, beamline, / IOCs, network installed
- 13611065: Entry Criteria: Ext Pred: Vacuum
- 13611025b: Entry Criteria: Ext Pred: Girders, beamline, / IOCs, network installed
- 13611026b: Entry Criteria: Ext Pred: Girders, beamline, / IOCs, network installed
- 13611036: Entry Criteria: Ext Pred: Girders, beamline, / IOCs, network installed
- 13611038: Entry Criteria: Ext Pred: Girders, beamline, / IOCs, network installed
- 13611038a: Entry Criteria: Ext Pred: Girders, beamline, / IOCs, network installed
- 13611039: Entry Criteria: Ext Pred: Girders, beamline, / IOCs, network installed
- 13611065a: Entry Criteria: Ext Pred: Vacuum
- 13611070: Entry Criteria: Ext Pred: Girders, beamline, / IOCs, network installed
- 13611075: Entry Criteria: Ext Pred: Girders, beamline, / IOCs, network installed
- 13611080: Entry Criteria: Ext Pred: Girders, beamline, / IOCs, network installed
- 13611037: Entry Criteria: Ext Pred: Girders, beamline, / IOCs, network installed
- 13611037a: Entry Criteria: Ext Pred: Girders, beamline, / IOCs, network installed
- 13611060: Entry Criteria: Ext Pred: Vacuum
- 13611038b: Entry Criteria: Ext Pred: Girders, beamline, / IOCs, network installed
- 13611085: Entry Criteria: Ext Pred: Girders, beamline, / IOCs, network installed
- 13611025: Entry Criteria: Ext Pred: Girders, beamline, / IOCs, network installed
- 13611055: Entry Criteria: Ext Pred: Girders, beamline, / IOCs, network installed
- 13611055a: Entry Criteria: Ext Pred: Girders, beamline, / IOCs, network installed
- 13611025c: Entry Criteria: Ext Pred: Girders, beamline, / IOCs, network installed
- 23611026b: Entry Criteria: Ext Pred: Girders, beamline, / IOCs, network installed
- 23611065a: Entry Criteria: Ext Pred: Vacuum
- 23611070: Entry Criteria: Ext Pred: Girders, beamline, / IOCs, network installed
- 23611075: Entry Criteria: Ext Pred: Girders, beamline, / IOCs, network installed
- 23611065aa: Entry Criteria: Ext Pred: Vacuum
- 23611075a: Entry Criteria: Ext Pred: Girders, beamline, / IOCs, network installed
- 23611080: Entry Criteria: Ext Pred: Girders, beamline, / IOCs, network installed
- 23611085: Entry Criteria: Ext Pred: Girders, beamline, / IOCs, network installed

| ID | Activity | Type | Duration | Start | Finish | Predecessors | Total float | Free float | Calendar | Resources | Cost | Original Activity ID Rebaseline | RESP - Responsibility | STRT%COMP for CM EVM | FNSH%COMP for CM EVM | CAM RESPONSIBLE | CR 12-005 | CR 12-026 | BOE Procurement | CR 13-015 | Post Rebaseline | CR 14-001 | BOE Labor | Advance Purchase Plan > 500K | EVMS Reporting Codes | CR 10-031 | CR 10-070 | CR 11-026 | CR 08-016 | CR 08-040 | CR 08-051 | CR 09-012 | BOE Expenses | BOE NOTES | BOE Adder | Milestone Level |
| --- | --- | --- | --- | --- | --- | --- | --- | --- | --- | --- | --- | --- | --- | --- | --- | --- | --- | --- | --- | --- | --- | --- | --- | --- | --- | --- | --- | --- | --- | --- | --- | --- | --- | --- | --- | --- |
| 23611090 | Assembly Procurement - Power Supplies/PC104/Timing Modules SPM BPMs |  | 77d | 2013-10-03 | 2014-02-03 | 23611075 FS-62d, 23611080 FS-62d, 23611075a FS-62d | 50d | 0d | 8/5 M-F w/JLAB Holidays ReBaseline | PROCUREMENT<$50K 60 | 1,703.71 | 23611090 | GARZA O | 1 | 1 | MIKE S | 12-005 | 12-026 | EV | 13-015 | PR | 14-001 |  |  |  |  |  |  |  |  |  |  |  |  |  |  |
| 23611095 | Installation Labor - Power Supplies/PC104/Timing Modules SPM BPMs Part A |  | 40d | 2013-10-03 | 2013-11-27 | 23611085a FS-77d, 23611090 FS-77d | 50d | 0d | 8/5 M-F w/JLAB Holidays ReBaseline | ELEC TECH [22.44 h] | 1,054.46 | 23611095 | GARZA O | 1 | 1 | MIKE S | 12-005 | 12-026 |  | 13-015 | PR | 14-001 | PE |  |  |  |  |  |  |  |  |  |  |  |  |  |
| 23611100 | Installation Procurement - Power Supplies/PC104/Timing Modules SPM BPMs |  | 77d | 2013-10-03 | 2014-02-03 | 23611095a FS-77d | 50d | 26d | 8/5 M-F w/JLAB Holidays ReBaseline | PROCUREMENT<$50K 60 | 1,916.67 | 23611100 | GARZA O | 1 | 1 | MIKE S | 12-005 | 12-026 | EV | 13-015 | PR | 14-001 |  |  |  |  |  |  |  |  |  |  |  |  |  |  |
| 23611015B | Procrmnt - Fab/Assy & Testing - SPM BPMs ELECTRONICS |  | 20d | 2013-11-01 | 2013-12-02 | 23611014B FS-20d, 23611014Ba FS-20d, 23611015A FS-83d, 23611014D FS-20d, 23611014D5 FS-20d | 24d | 0d | 8/5 M-F w/JLAB Holidays ReBaseline | PROCUREMENT<$50K 60 | 55,902.92 | 23611015B | GARZA O | 1 | 1 | MIKE S | 12-005 | 12-026 | EV | 13-015 | PR | 14-001 |  | APP | D | 10-031 | 10-070 | 11-026 |  |  |  |  |  |  |  |  |
| 23611025 | System Installation - Electronics SPM BPMs Part A |  | 19d | 2013-11-01 | 2013-11-27 | 23611015B FS-20d | 29d | 0d | 8/5 M-F w/JLAB Holidays ReBaseline | ELEC TECH [48.36 h] | 2,272.44 | 23611025 | GARZA O | 1 | 1 | MIKE S | 12-005 | 12-026 |  | 13-015 | PR | 14-001 | PE | APP |  | 10-031 | 10-070 | 11-026 | 08-016 | 08-040 | 08-051 | 09-012 |  |  |  |  |
| 23611025b | System Installation Contract Labor - Electronics SPM BPMs |  | 20d | 2013-11-01 | 2013-12-02 | 23611015B FS-20d | 86d | 62d | 8/5 M-F w/JLAB Holidays ReBaseline | SUPPLIES & MATERIALS | 17,303.29 | 23611025a5 | GARZA O | 1 | 1 | MIKE S | 12-005 | 12-026 |  | 13-015 | PR | 14-001 |  |  |  |  |  |  |  |  |  |  | PE |  |  |  |
| 23611025c | System Installation Software Support - Electronics SPM BPMs Part A |  | 19d | 2013-11-01 | 2013-11-27 | 23611015B FS-20d | 24d | 0d | 8/5 M-F w/JLAB Holidays ReBaseline | COMP SCIENT [76.78 h] | 5,364.62 | 23611025c | GARZA O | 1 | 1 | MIKE S | 12-005 | 12-026 |  | 13-015 | PR | 14-001 | PE |  |  |  |  |  |  |  |  |  |  |  |  |  |
| 23611025a | System Installation - Electronics SPM BPMs Part B |  | 58d | 2013-12-02 | 2014-03-04 | 23611025 | 29d | 5d | 8/5 M-F w/JLAB Holidays ReBaseline | ELEC TECH [125.49 h] | 5,896.78 | 23611025 | GARZA O | 1 | 1 | MIKE S | 12-005 | 12-026 |  | 13-015 | PR | 14-001 | PE | APP |  | 10-031 | 10-070 | 11-026 | 08-016 | 08-040 | 08-051 | 09-012 |  |  |  |  |
| 23611025ca | System Installation Software Support - Electronics SPM BPMs Part B |  | 78d | 2013-12-02 | 2014-04-01 | 23611025c | 24d | 0d | 8/5 M-F w/JLAB Holidays ReBaseline | COMP SCIENT [267.94 h] | 18,720.97 | 23611025c | GARZA O | 1 | 1 | MIKE S | 12-005 | 12-026 |  | 13-015 | PR | 14-001 | PE |  |  |  |  |  |  |  |  |  |  |  |  |  |
| 23611085a | Assembly Labor - Power Supplies/PC104/Timing Modules SPM BPMs Part b |  | 37d | 2013-12-02 | 2014-02-03 | 23611085 | 50d | 0d | 8/5 M-F w/JLAB Holidays ReBaseline | ELEC TECH [261.41 h] | 12,283.66 | 23611085 | GARZA O | 1 | 1 | MIKE S | 12-005 | 12-026 |  | 13-015 | PR | 14-001 | PE |  |  |  |  |  |  |  |  |  |  |  |  |  |
| 23611095a | Installation Labor - Power Supplies/PC104/Timing Modules SPM BPMs Part B |  | 37d | 2013-12-02 | 2014-02-03 | 23611095 | 50d | 0d | 8/5 M-F w/JLAB Holidays ReBaseline | ELEC TECH [17.65 h] | 829.37 | 23611095 | GARZA O | 1 | 1 | MIKE S | 12-005 | 12-026 |  | 13-015 | PR | 14-001 | PE |  |  |  |  |  |  |  |  |  |  |  |  |  |
| 23611914LOEa | FY14 Mngmnt Effort for BPMs Part B |  | 181d | 2013-12-02 | 2014-08-26 | 23611914LOE | 67d | 47d | 8/5 M-F w/JLAB Holidays ReBaseline | SCIENTIST [55.17 h] | 4,147.68 | 23611914LOE | GARZA O | 1 | 1 | MIKE S |  |  |  | 13-015 | PR | 14-001 | PE |  | E |  |  |  |  |  |  |  |  |  |  |  |
| 23611036 | First Article Cavities - nA BPM Sys |  | 39d | 2014-01-07 | 2014-03-03 | 9-140M FS+60d | 23d | 0d | 8/5 M-F w/JLAB Holidays ReBaseline | MECH ENG [272 h]; ELEC ENG [265.2 h] | 40,234.72 | 23611036 | GARZA O | 1 | 1 | MIKE S | 12-005 | 12-026 | EJ | 13-015 | PR | 14-001 | PE |  |  |  |  |  |  |  |  |  | EJ | Cost of materials has increased |  |  |
| 23611065a5 | System Documentation - nA BPMs |  | 167d | 2014-03-04 | 2014-10-27 | 23611035M FS-21d | 24d | 4d | 8/5 M-F w/JLAB Holidays ReBaseline | ELEC DES [175.44 h] | 9,435.16 | 23611065a5 | GARZA O | 1 | 1 | MIKE S | 12-005 | 12-026 |  | 13-015 | PR | 14-001 | PE |  |  | 10-031 | 10-070 |  |  |  |  |  |  |  |  |  |
| 23611027 | Hook-up & Check-out H-D B/L BPMs |  | 15d | 2014-03-12 | 2014-04-01 | 23458065a, 23611025b, 23458065, 23611025a, 23611025ca FS-15d, 23611100 | 24d | 0d | 8/5 M-F w/JLAB Holidays ReBaseline | COMP SCIENT [68 h]; ELEC TECH [68 h] | 7,946.48 | 23611027 | GARZA O | 1 | 1 | MIKE S | 12-005 | 12-026 |  | 13-015 | PR | 14-001 | PE |  | H | 10-031 | 10-070 | 11-026 |  |  |  |  |  |  |  |  |
| 23611037 | Procurement Labor Cavities - nA BPM Sys |  | 82d | 2014-03-31 | 2014-07-24 | 23611036 FS+19d | 23d | 0d | 8/5 M-F w/JLAB Holidays ReBaseline | MECH TECH [68 h]; ELEC TECH [68 h] | 6,413.08 | 23611037 | GARZA O | 1 | 1 | MIKE S | 12-005 | 12-026 | EJ | 13-015 | PR | 14-001 | PE |  |  |  |  |  |  |  |  |  | EJ | Additional design manpower required or unknown at this time' | NO |  |
| 23611037a | Procurement Cavities - nA BPM Sys |  | 82d | 2014-03-31 | 2014-07-24 | 23611037 FS-82d, 23611036 FS-1d | 23d | 3d | 8/5 M-F w/JLAB Holidays ReBaseline | PROCUREMENT<$50K 60 | 180,870.59 | 23611037a | GARZA O | 1 | 1 | MIKE S | 12-005 | 12-026 | EJ | 13-015 | PR | 14-001 | PE |  |  |  |  |  |  |  |  |  | EJ | Higher material costs |  |  |
| 23611038 | First Article Unit RF Receiver - nA BPM Sys |  | 49d | 2014-03-31 | 2014-06-06 | 9-140M FS+118d | 86d | 0d | 8/5 M-F w/JLAB Holidays ReBaseline | ELEC ENG [245 h] | 18,406.85 | 23611038 | GARZA O | 1 | 1 | MIKE S | 12-005 | 12-026 |  | 13-015 | PR | 14-001 | PE |  |  |  |  |  |  |  |  |  |  |  |  |  |
| 23611038a | First Article Unit Digital IF - nA BPM Sys |  | 29d | 2014-03-31 | 2014-05-08 | 9-140M FS+118d | 86d | 0d | 8/5 M-F w/JLAB Holidays ReBaseline | ELEC ENG [164.33 h] | 12,346.11 | 23611038a | GARZA O | 1 | 1 | MIKE S | 12-005 | 12-026 |  | 13-015 | PR | 14-001 | PE |  |  |  |  |  |  |  |  |  |  |  |  |  |
| 23611038b | First Article Enclosure nA Receiver - nA BPM Sys |  | 19d | 2014-03-31 | 2014-04-24 | 23611038a FS-29d, 23611038 FS-49d | 86d | 66d | 8/5 M-F w/JLAB Holidays ReBaseline | ELEC ENG [68 h]; ELEC TECH [129.2 h] | 11,179.95 | 23611038b | GARZA O | 1 | 1 | MIKE S | 12-005 | 12-026 |  | 13-015 | PR | 14-001 | PE |  |  |  |  |  |  |  |  |  |  |  |  |  |
| 23611060 | Software support - nA BPMs |  | 107d | 2014-03-31 | 2014-08-28 | 23611055 FS-160d, 23611050 FS-147d | 65d | 45d | 8/5 M-F w/JLAB Holidays ReBaseline | COMP SCIENT [544 h] | 38,009.28 | 23611060 | GARZA O | 1 | 1 | MIKE S | 12-005 | 12-026 |  | 13-015 | PR | 14-001 | PE |  |  | 10-031 | 10-070 |  |  |  |  |  |  |  |  |  |
| 23611035M | SPM BPMs Comp | milestone | 0d | 2014-04-01 | 2014-04-01 | 23611027 | 24d | 0d | 8/5 M-F w/JLAB Holidays ReBaseline |  |  | 23611035M | GARZA O | 1 | 1 | MIKE S | 12-005 | 12-026 |  | 13-015 | PR |  |  |  | M |  | 10-070 | 11-026 |  |  |  |  |  |  |  | 6 |
| 23611039 | Procurement Labor Electronics - nA BPM Sys |  | 19d | 2014-05-01 | 2014-05-28 | 9-140M FS+141d | 20d | 0d | 8/5 M-F w/JLAB Holidays ReBaseline | ELEC TECH [129.2 h]; ELEC ENG [51 h] | 9,902.74 | 23611039 | GARZA O | 1 | 1 | MIKE S | 12-005 | 12-026 |  | 13-015 | PR | 14-001 | PE |  |  |  |  |  |  |  |  |  |  |  |  |  |
| 23611040 | Procurements Electronics - nA BPM Sys |  | 19d | 2014-05-01 | 2014-05-28 | 23611039 FS-19d | 20d | 0d | 8/5 M-F w/JLAB Holidays ReBaseline | PROCUREMENT<$50K 60 | 35,751.25 | 23611040 | GARZA O | 1 | 1 | MIKE S | 12-005 | 12-026 | EV | 13-015 | PR | 14-001 |  | APP |  |  | 10-070 |  |  |  |  |  |  |  |  |  |
| 23611045 | Assembly Electronics Labor - nA BPM Sys |  | 83d | 2014-06-30 | 2014-10-24 | 23611040 FS+22d | 20d | 0d | 8/5 M-F w/JLAB Holidays ReBaseline | ELEC TECH [340 h]; ELEC ENG [68 h] | 21,085.44 | 23611045 | GARZA O | 1 | 1 | MIKE S | 12-005 | 12-026 |  | 13-015 | PR | 14-001 | PE | APP |  |  | 10-070 |  |  |  |  |  |  |  |  |  |
| 23611050 | Assembly & Testing Procurement - nA BPM Sys |  | 83d | 2014-06-30 | 2014-10-24 | 23611045 FS-83d, 23611040 FS-1d | 20d | 0d | 8/5 M-F w/JLAB Holidays ReBaseline | PROCUREMENT<$50K 60 NO ESCALATION FY15 | 7,240.76 | 23611050 | GARZA O | 1 | 1 | MIKE S | 12-005 | 12-026 | PE | 13-015 | PR | 14-001 | PE |  |  |  | 10-070 |  |  |  |  |  |  |  |  |  |
| 23611055 | System Installation Electronics - nA BPM Sytem (BPM) |  | 67d | 2014-07-30 | 2014-10-31 | 23458065, 23611050 FS-62d, 23611038b, 23458065a, 23611037a | 20d | 0d | 8/5 M-F w/JLAB Holidays ReBaseline | ELEC TECH [170 h] | 7,988.3 | 23611055 | GARZA O | 1 | 1 | MIKE S | 12-005 | 12-026 |  | 13-015 | PR | 14-001 | PE | APP |  | 10-031 | 10-070 |  | 08-016 |  |  | 09-012 |  |  |  |  |
| 23611055a | System Installation Electronics Contract Labor - nA BPM Sytem (BPM) |  | 67d | 2014-07-30 | 2014-10-31 | 23611055 FS-67d, 23611038b, 23611037a | 20d | 0d | 8/5 M-F w/JLAB Holidays ReBaseline | PROCUREMENT<$50K 60 NO ESCALATION FY15 | 14,481.52 | 23611055a | GARZA O | 1 | 1 | MIKE S | 12-005 | 12-026 | PE | 13-015 | PR | 14-001 |  | APP |  |  |  |  |  |  |  |  |  |  |  |  |
| 23611065M | nA BPMs Comp | milestone | 0d | 2014-10-31 | 2014-10-31 | 23611065a5, 23611060, 23611065a, 23611914LOEa, 23611055a, 23611065aa | 20d | 12d | 8/5 M-F w/JLAB Holidays ReBaseline |  |  | 23611065M | GARZA O | 1 | 1 | MIKE S | 12-005 | 12-026 |  | 13-015 | PR |  |  |  | M | 10-031 | 10-070 |  |  |  |  |  |  |  |  | 6 |

Notes:
- 23611090: Entry Criteria: Ext Pred: Girders, beamline, / IOCs, network installed
- 23611095: Entry Criteria: Ext Pred: Girders, beamline, / IOCs, network installed
- 23611100: Entry Criteria: Ext Pred: Girders, beamline, / IOCs, network installed
- 23611025: Entry Criteria: Ext Pred: Girders, beamline, / IOCs, network installed
- 23611025b: Entry Criteria: Ext Pred: Girders, beamline, / IOCs, network installed
- 23611025c: Entry Criteria: Ext Pred: Girders, beamline, / IOCs, network installed
- 23611025a: Entry Criteria: Ext Pred: Girders, beamline, / IOCs, network installed
- 23611025ca: Entry Criteria: Ext Pred: Girders, beamline, / IOCs, network installed
- 23611085a: Entry Criteria: Ext Pred: Girders, beamline, / IOCs, network installed
- 23611095a: Entry Criteria: Ext Pred: Girders, beamline, / IOCs, network installed
- 23611036: Entry Criteria: Ext Pred: Girders, beamline, / IOCs, network installed
- 23611065a5: Entry Criteria: Ext Pred: Vacuum
- 23611027: Entry Criteria: Ext Pred: Girders, beamline, / IOCs, network installed
- 23611037: Entry Criteria: Ext Pred: Girders, beamline, / IOCs, network installed
- 23611037a: Entry Criteria: Ext Pred: Girders, beamline, / IOCs, network installed
- 23611038: Entry Criteria: Ext Pred: Girders, beamline, / IOCs, network installed
- 23611038a: Entry Criteria: Ext Pred: Girders, beamline, / IOCs, network installed
- 23611038b: Entry Criteria: Ext Pred: Girders, beamline, / IOCs, network installed
- 23611060: Entry Criteria: Ext Pred: Vacuum
- 23611039: Entry Criteria: Ext Pred: Girders, beamline, / IOCs, network installed
- 23611055: Entry Criteria: Ext Pred: Girders, beamline, / IOCs, network installed
- 23611055a: Entry Criteria: Ext Pred: Girders, beamline, / IOCs, network installed

| ID | WBS | Activity | Type | Duration | Start | Finish | Predecessors | Total float | Free float | Calendar | Resources | Cost | RESP - Responsibility | STRT%COMP for CM EVM | FNSH%COMP for CM EVM | CAM RESPONSIBLE | CR 08-058 | CR 09-035 | CR 10-070 | CR 07-024 | CR 12-053 | CR 13-014 | CR 08-016 | CR 09-012 | CR 10-031 | Milestone Level | ReBaseline Actuals Adjustment | Original Activity ID Rebaseline | BOE Procurement | BOE Labor | BOE Expenses | CR 13-015 | Post Rebaseline | EVMS Reporting Codes | CR 14-001 |
| --- | --- | --- | --- | --- | --- | --- | --- | --- | --- | --- | --- | --- | --- | --- | --- | --- | --- | --- | --- | --- | --- | --- | --- | --- | --- | --- | --- | --- | --- | --- | --- | --- | --- | --- | --- |
|  | 2 | **1.3.6.1.2 HARPS** |  |  | 2009-01-02 | 2013-09-30 |  |  |  |  |  |  |  |  |  |  |  |  |  |  |  |  |  |  |  |  |  |  |  |  |  |  |  |  |  |
| 13612909LOE |  | FY09 Mngmnt Effort for Harps |  | 189d | 2009-01-02 | 2009-09-30 | 13612909LOEX | 20d | 0d |  | SR STAFF [24.39 h] | 2,508.27 | GARZA O | 1 | 1 | MIKE S | 08-058 |  |  |  |  |  |  |  |  |  |  |  |  |  |  |  |  |  |  |
| 13612910LOE |  | FY10 Mngmnt Effort for Harps |  | 248d | 2009-10-01 | 2010-09-30 | 13612909LOE | 20d | 0d |  | SR STAFF [32 h] | 3,395.84 | GARZA O | 1 | 1 | MIKE S |  |  |  |  |  |  |  |  |  |  |  |  |  |  |  |  |  |  |  |
| 13612911LOE |  | FY11 Mngmnt Effort for Harps |  | 248d | 2010-10-01 | 2011-09-30 | 13612910LOE | 20d | 0d |  | SR STAFF [32 h] | 3,504.32 | GARZA O | 1 | 1 | MIKE S |  |  |  |  |  |  |  |  |  |  |  |  |  |  |  |  |  |  |  |
| 13612011 |  | LABOR Prep for Harp Sys Procuremnts |  | 40d | 2011-10-03 | 2011-11-29 | 9-120M, 121612030, 121612035 | 170d | 0d |  | ELEC ENG [40 h]; ELEC TECH [40 h] | 4,587.6 | GARZA O | 1 | 1 | MIKE S |  | 09-035 | 10-070 |  |  |  |  |  |  |  |  |  |  |  |  |  |  |  |  |
| 13612014 |  | Vendors Fab Harp Sys Pieces & Components |  | 95d | 2011-10-03 | 2012-02-24 | 13612011 FS-40d | 170d | 0d |  | PROCUREMENT<$50K 60 | 162,630.82 | GARZA O | 1 | 1 | MIKE S |  | 09-035 | 10-070 | 07-024 |  |  |  |  |  |  |  |  |  |  |  |  |  |  |  |
| 13612912LOE |  | FY12 Mngmnt Effort for Harps |  | 247d | 2011-10-03 | 2012-09-28 | 13612911LOE | 20d | 0d |  | SR STAFF [32 h] | 3,616 | GARZA O | 1 | 1 | MIKE S |  |  |  |  |  |  |  |  |  |  |  |  |  |  |  |  |  |  |  |
| 13612015 |  | Harp Sys Fab & Assy |  | 125d | 2012-02-27 | 2012-08-21 | 13612014 | 170d | 0d |  | SCIENTIST [120 h]; SUPPLIES & MATERIALS; MECH TECH [40 h]; ELEC DES [40 h]; ELEC TECH [320 h]; ELEC ENG [60 h] | 33,645.02 | GARZA O | 1 | 1 | MIKE S |  |  | 10-070 |  |  |  |  |  |  |  |  |  |  |  |  |  |  |  |  |
| 13612020 |  | Harp Component Testing FY12 |  | 27d | 2012-08-22 | 2012-09-28 | 13612015, 9-120M | 170d | 0d |  | COMP SCIENT [61.71 h]; ELEC TECH [92.57 h]; ELEC ENG [30.86 h] | 10,312 | GARZA O | 1 | 1 | MIKE S |  |  | 10-070 |  | 12-053 |  |  |  |  |  |  |  |  |  |  |  |  |  |  |
| 13612020b |  | Harp Component Testing Procurement |  | 35d | 2012-08-22 | 2012-10-10 | 13612015, 9-120M | 170d | 0d |  | PROCUREMENT<$50K 60 NO ESCALATION FY13 | 2,340.02 | GARZA O | 1 | 1 | MIKE S |  |  | 10-070 |  | 12-053 |  |  |  |  |  |  |  |  |  |  |  |  |  |  |
| 13612030 |  | Harp Systems Software Implementn & Cmmssng FY12 |  | 2d | 2012-09-27 | 2012-09-28 | 13612025 FS-70d | 170d | 0d |  | COMP SCIENT [5.33 h]; ELEC ENG [0.89 h]; ELEC TECH [0.89 h]; SCIENTIST [2.67 h] | 640.36 | GARZA O | 1 | 1 | MIKE S |  |  | 10-070 |  | 12-053 |  |  |  |  |  |  |  |  |  |  |  |  |  |  |
| 13612020a |  | Harp Component Testing FY13 |  | 8d | 2012-10-01 | 2012-10-10 | 13612020 | 170d | 0d |  | ELEC ENG [9.14 h]; COMP SCIENT [18.29 h]; ELEC TECH [27.43 h] | 3,153.06 | GARZA O | 1 | 1 | MIKE S |  |  | 10-070 |  | 12-053 |  |  |  |  |  |  |  |  |  |  |  |  |  |  |
| 13612035 |  | Harp Systems Software Implementn & Cmmssng FY13 |  | 88d | 2012-10-01 | 2013-02-12 | 13612030 | 170d | 0d |  | COMP SCIENT [234.67 h]; ELEC ENG [39.11 h]; ELEC TECH [39.11 h]; SCIENTIST [117.33 h] | 29,066.84 | GARZA O | 1 | 1 | MIKE S |  |  | 10-070 |  | 12-053 |  |  |  |  |  |  |  |  |  |  |  |  |  |  |
| 13612913LOE |  | FY13 Mngmnt Effort for Harps |  | 228d | 2012-10-01 | 2013-08-30 | 13612912LOE | 20d |  |  | SR STAFF [29.42 h] | 3,430.37 | GARZA O | 1 | 1 | MIKE S |  |  |  |  |  | 13-014 |  |  |  |  |  |  |  |  |  |  |  |  |  |
| 13612025 |  | Harp Sys Implementn |  | 60d | 2012-10-11 | 2013-01-14 | 1362025, 13612020a, 13612020b, 2-02M | 170d | 0d |  | ELEC ENG [40 h]; MECH TECH [40 h]; ELEC TECH [360 h]; PROCUREMENT<$50K 60; SUPPLIES & MATERIALS; ELEC DES [40 h] | 34,912.94 | GARZA O | 1 | 1 | MIKE S |  |  | 10-070 |  |  |  | 08-016 | 09-012 | 10-031 |  |  |  |  |  |  |  |  |  |  |
| 13612035M |  | Harp Sys Comp | milestone | 0d | 2013-02-12 | 2013-02-12 | 13612035 | 170d |  |  |  |  | GARZA O | 1 | 1 | MIKE S |  |  | 10-070 |  |  |  |  |  |  | 6 |  |  |  |  |  |  |  |  |  |
| 13612950 |  | Re-Baseline Actuals Adjustment |  | 1d | 2013-08-30 | 2013-08-30 | 9-130M FS+227d | 20d |  |  | PROCUREMENT>$50K 69 NO ESCALATION | 93,141.43 | GARZA O | 1 | 1 | MIKE S |  |  |  |  |  | 13-014 |  |  |  |  | ADJ |  |  |  |  |  |  |  |  |
| 23612030 |  | Harp Sys Implementn Labor |  | 20d | 2013-09-03 | 2013-09-30 | 9-130M FS+228d, 23458065a FS-26d, 23458065 FS-26d | 30d | 0d | 8/5 M-F w/JLAB Holidays ReBaseline | ELEC ENG [52.8 h]; ELEC DES [12 h]; ELEC TECH [78 h]; SUPPLIES & MATERIALS | 10,721.93 | GARZA O | 1 | 1 | MIKE S |  |  | 10-070 |  |  |  | 08-016 | 09-012 | 10-031 |  |  | 23612030 | PE | PE | PE | 13-015 | PR |  |  |
| 23612035 |  | Harp Systems Software Implementn & Cmmssng |  | 20d | 2013-09-03 | 2013-09-30 | 23612030 FS-20d | 30d | 0d | 8/5 M-F w/JLAB Holidays ReBaseline | COMP SCIENT [96 h]; ELEC ENG [16 h]; ELEC TECH [16 h] | 8,393.76 | GARZA O | 1 | 1 | MIKE S |  |  | 10-070 |  | 12-053 |  |  |  |  |  |  | 23612035 |  | PE |  | 13-015 | PR |  |  |
| 23612913LOE |  | FY13 Mngmnt Effort for Harps |  | 20d | 2013-09-03 | 2013-09-30 | 9-130M FS+228d | 89d |  | 8/5 M-F w/JLAB Holidays ReBaseline | SCIENTIST [2.68 h] | 195.26 | GARZA O | 1 | 1 | MIKE S |  |  |  |  |  |  |  |  |  |  |  | 23612913LOE |  | PE |  | 13-015 | PR | E |  |
| 23612035M |  | Harp Sys Comp | milestone | 0d | 2013-09-30 | 2013-09-30 | 23612035 | 30d | 19d | 8/5 M-F w/JLAB Holidays ReBaseline |  |  | GARZA O | 1 | 1 | MIKE S |  |  | 10-070 |  |  |  |  |  |  | 6 |  | 23612035M |  |  |  | 13-015 | PR | M |  |
|  | 3 | **1.3.6.1.3 VIEWERS** |  |  | 2009-01-02 | 2013-12-02 |  |  |  |  |  |  |  |  |  |  |  |  |  |  |  |  |  |  |  |  |  |  |  |  |  |  |  |  |  |
| 13613909LOE |  | FY09 Mngmnt Effort for Viewer Syss |  | 189d | 2009-01-02 | 2009-09-30 | 13613909LOEX | 20d | 0d |  | SR STAFF [24.39 h] | 2,508.27 | GARZA O | 1 | 1 | MIKE S | 08-058 |  |  |  |  |  |  |  |  |  |  |  |  |  |  |  |  |  |  |
| 13613910LOE |  | FY10 Mngmnt Effort for Viewer Syss |  | 248d | 2009-10-01 | 2010-09-30 | 13613909LOE | 20d | 0d |  | SR STAFF [32 h] | 3,395.84 | GARZA O | 1 | 1 | MIKE S |  |  |  |  |  |  |  |  |  |  |  |  |  |  |  |  |  |  |  |
| 13613911LOE |  | FY11 Mngmnt Effort for Viewer Syss |  | 248d | 2010-10-01 | 2011-09-30 | 13613910LOE | 20d | 0d |  | SR STAFF [32 h] | 3,504.32 | GARZA O | 1 | 1 | MIKE S |  |  |  |  |  |  |  |  |  |  |  |  |  |  |  |  |  |  |  |
| 13613912LOE |  | FY12 Mngmnt Effort for Viewer Syss |  | 247d | 2011-10-03 | 2012-09-28 | 13613911LOE | 20d | 0d |  | SR STAFF [32 h] | 3,616 | GARZA O | 1 | 1 | MIKE S |  |  |  |  |  |  |  |  |  |  |  |  |  |  |  |  |  |  |  |
| 13613014 |  | Procurements for Viewer Syss |  | 80d | 2012-02-03 | 2012-05-25 | 121613040M, 9-120M FS+80d | 20d | 0d |  | ELEC TECH [160 h]; SCIENTIST [100 h]; TRAVEL; SUPPLIES & MATERIALS; PROCUREMENT<$50K 60; ELEC ENG [80 h] | 86,609.05 | GARZA O | 1 | 1 | MIKE S |  |  | 10-070 |  |  |  |  |  |  |  |  |  |  |  |  |  |  |  |  |
| 13613015 |  | Fab & Assy of Viewer Syss FY12 |  | 87d | 2012-05-29 | 2012-09-28 | 13613014, 9-120M | 20d | 0d |  | SUPPLIES & MATERIALS; TRAVEL; SCIENTIST [38.67 h]; ELEC ENG [77.33 h]; ELEC DES [19.33 h]; MECH TECH [19.33 h]; ELEC TECH [193.33 h] | 22,812.16 | GARZA O | 1 | 1 | MIKE S |  |  | 10-070 |  | 12-053 |  | 08-016 | 09-012 |  |  |  |  |  |  |  |  |  |  |  |
| 13613015b |  | Fab & Assy of Viewer Syss Procurement |  | 180d | 2012-05-29 | 2013-02-20 | 9-120M, 13613014 | 20d | 0d |  | PROCUREMENT<$50K 60 NO ESCALATION FY13 | 11,700.06 | GARZA O | 1 | 1 | MIKE S |  |  | 10-070 |  | 12-053 |  | 08-016 | 09-012 |  |  |  |  |  |  |  |  |  |  |  |
| 13613015a |  | Fab & Assy of Viewer Syss FY13 |  | 93d | 2012-10-01 | 2013-02-20 | 13613015 | 20d | 0d |  | SUPPLIES & MATERIALS; TRAVEL; SCIENTIST [41.33 h]; ELEC ENG [82.67 h]; ELEC DES [20.67 h]; MECH TECH [20.67 h]; ELEC TECH [206.67 h] | 25,164.63 | GARZA O | 1 | 1 | MIKE S |  |  | 10-070 |  | 12-053 |  | 08-016 | 09-012 |  |  |  |  |  |  |  |  |  |  |  |
| 13613913LOE |  | FY13 Mngmnt Effort for Viewer Syss |  | 228d | 2012-10-01 | 2013-08-30 | 13613912LOE | 20d |  |  | SR STAFF [29.42 h] | 3,430.37 | GARZA O | 1 | 1 | MIKE S |  |  |  |  |  | 13-014 |  |  |  |  |  |  |  |  |  |  |  |  |  |
| 13613020 |  | Testing of Viewer Sys Compnts |  | 125d | 2013-02-21 | 2013-08-16 | 13613015a, 13613015b | 20d | 0d |  | ELEC ENG [40 h]; ELEC TECH [160 h]; COMP SCIENT [320 h]; SCIENTIST [20 h]; PROCUREMENT<$50K 60 | 39,359.86 | GARZA O | 1 | 1 | MIKE S |  |  | 10-070 |  |  |  |  |  |  |  |  |  |  |  |  |  |  |  |  |
| 13613030 |  | Software Implementn Viewer Systems |  | 20d | 2013-08-05 | 2013-08-30 | 13613025 FS-20d, 121613040M | 20d |  |  | SCIENTIST [4.85 h]; COMP SCIENT [19.39 h]; ELEC ENG [14.55 h]; ELEC TECH [29.09 h] | 4,050.35 | GARZA O | 1 | 1 | MIKE S |  |  | 10-070 |  |  | 13-014 |  |  |  |  |  |  |  |  |  |  |  |  |  |
| 13613025 |  | Implementn of Viewer Syss |  | 10d | 2013-08-19 | 2013-08-30 | 13613020, 1362025 | 20d | 0d |  | ELEC DES [2.86 h]; MECH TECH [2.86 h]; ELEC TECH [20 h]; PROCUREMENT<$50K 60 NO ESCALATION FY14; ELEC ENG [2.86 h] | 1,398.7 | GARZA O | 1 | 1 | MIKE S |  |  | 10-070 |  |  | 13-014 | 08-016 | 09-012 |  |  |  |  |  |  |  |  |  |  |  |
| 13613950 |  | Re-Baseline Actuals Adjustment |  | 1d | 2013-08-30 | 2013-08-30 | 9-130M FS+227d | 20d |  |  | PROCUREMENT>$50K 69 NO ESCALATION | 163,320.24 | GARZA O | 1 | 1 | MIKE S |  |  |  |  |  | 13-014 |  |  |  |  | ADJ |  |  |  |  |  |  |  |  |
| 23613025a |  | Implementn of Viewer Syss Labor |  | 20d | 2013-09-03 | 2013-09-30 | 23458065 FS-100d, 23458065a FS-100d, 9-130M FS+228d | 30d | 0d | 8/5 M-F w/JLAB Holidays ReBaseline | ELEC DES [10 h]; ELEC TECH [70 h] | 3,709 | GARZA O | 1 | 1 | MIKE S |  |  | 10-070 |  |  |  | 08-016 | 09-012 |  |  |  | 23613025a |  | PE |  | 13-015 | PR |  |  |
| 23613030 |  | Software Implementn Viewer Systems |  | 20d | 2013-09-03 | 2013-09-30 | 23613025a FS-20d | 30d | 0d | 8/5 M-F w/JLAB Holidays ReBaseline | COMP SCIENT [160 h]; ELEC TECH [120 h] | 16,298.4 | GARZA O | 1 | 1 | MIKE S |  |  | 10-070 |  |  |  |  |  |  |  |  | 23613030 |  | PE |  | 13-015 | PR |  |  |
| 23613913LOE |  | FY13 Mngmnt Effort for Viewer Syss |  | 20d | 2013-09-03 | 2013-09-30 | 9-130M FS+228d | 89d |  | 8/5 M-F w/JLAB Holidays ReBaseline | SCIENTIST [2.68 h] | 195.26 | GARZA O | 1 | 1 | MIKE S |  |  |  |  |  |  |  |  |  |  |  | 23613913LOE |  | PE |  | 13-015 | PR | E |  |
| 23613035M |  | Viewers Sys Comp | milestone | 0d | 2013-09-30 | 2013-09-30 | 23613025a, 23613030 | 30d | 19d | 8/5 M-F w/JLAB Holidays ReBaseline |  |  | GARZA O | 1 | 1 | MIKE S |  |  | 10-070 |  |  |  |  |  |  | 6 |  | 23613035M |  |  |  | 13-015 | PR | M |  |
| 23613050 |  | SLM System Controls |  | 43d | 2013-10-01 | 2013-12-02 | 9-140M | 73d | 55d | 8/5 M-F w/JLAB Holidays ReBaseline | ELEC TECH [28 h]; PROCUREMENT<$50K 60 | 10,086.87 | GARZA O | 1 | 1 | MIKE S |  |  | 10-070 |  |  |  |  |  |  |  |  | 23613050 | PE | PE |  | 13-015 | PR |  | 14-001 |

Notes:
- 13612025: Entry Criteria: Ext Pred: Girders, beamline, / IOCs and network installed
- 23612030: Entry Criteria: Ext Pred: Girders, beamline, / IOCs and network installed
- 13613030: Entry Criteria: Ext Pred: Beam
- 13613025: Entry Criteria: Ext Pred: Girders, beamline, / IOCs and network installed
- 23613025a: Entry Criteria: Ext Pred: Girders, beamline, / IOCs and network installed
- 23613030: Entry Criteria: Ext Pred: Beam
- 23613050: Entry Criteria: Ext Pred: Beam

| ID | WBS | Activity | Type | Duration | Start | Finish | Predecessors | Total float | Free float | Calendar | Resources | Cost | RESP - Responsibility | STRT%COMP for CM EVM | FNSH%COMP for CM EVM | CAM RESPONSIBLE | CR 08-058 | CR 10-070 | CR 11-026 | CR 13-014 | ReBaseline Actuals Adjustment | Original Activity ID Rebaseline | BOE Procurement | BOE Labor | BOE Expenses | CR 13-015 | Post Rebaseline | CR 14-001 | EVMS Reporting Codes | CR 10-031 | CR 12-005 | CR 12-026 | CR 12-025 | Milestone Level | CR 12-018 | CR 12-037 | CR 11-001 | CR 08-016 | CR 09-012 | CR 12-053 | CR 13-003 |
| --- | --- | --- | --- | --- | --- | --- | --- | --- | --- | --- | --- | --- | --- | --- | --- | --- | --- | --- | --- | --- | --- | --- | --- | --- | --- | --- | --- | --- | --- | --- | --- | --- | --- | --- | --- | --- | --- | --- | --- | --- | --- |
|  | 4 | **1.3.6.1.4 BEAM-BASED FEEDBACK SYSTEMS** |  |  | 2009-01-02 | 2014-09-22 |  |  |  |  |  |  |  |  |  |  |  |  |  |  |  |  |  |  |  |  |  |  |  |  |  |  |  |  |  |  |  |  |  |  |  |
| 13614909LOE |  | FY09 FFB Sys Mangement Effort |  | 189d | 2009-01-02 | 2009-09-30 | 13614909LOEX | 20d | 0d |  | SR STAFF [3.05 h] | 313.66 | GARZA O | 1 | 1 | MIKE S | 08-058 |  |  |  |  |  |  |  |  |  |  |  |  |  |  |  |  |  |  |  |  |  |  |  |  |
| 13614910LOE |  | FY10 FFB Sys Mangement Effort |  | 248d | 2009-10-01 | 2010-09-30 | 13614909LOE | 20d | 0d |  | SR STAFF [4 h] | 424.48 | GARZA O | 1 | 1 | MIKE S |  |  |  |  |  |  |  |  |  |  |  |  |  |  |  |  |  |  |  |  |  |  |  |  |  |
| 13614911LOE |  | FY11 FFB Sys Mangement Effort |  | 248d | 2010-10-01 | 2011-09-30 | 13614910LOE | 20d | 0d |  | SR STAFF [112 h] | 12,265.12 | GARZA O | 1 | 1 | MIKE S |  |  |  |  |  |  |  |  |  |  |  |  |  |  |  |  |  |  |  |  |  |  |  |  |  |
| 13614014 |  | FFB Sys Prcrmnts |  | 60d | 2013-02-06 | 2013-05-01 | 121614035M, 2-02M FS+180d | 65d | 0d |  | ELEC TECH [60 h]; SUPPLIES & MATERIALS; PROCUREMENT<$50K 60 | 101,008.99 | GARZA O | 1 | 1 | MIKE S |  | 10-070 | 11-026 |  |  |  |  |  |  |  |  |  |  |  |  |  |  |  |  |  |  |  |  |  |  |
| 13614015 |  | FFB Sys Fabriation & Assy |  | 40d | 2013-05-02 | 2013-06-27 | 13614014 | 65d |  |  | PROCUREMENT<$50K 60; ELEC TECH [120 h]; ELEC DES [40 h]; SUPPLIES & MATERIALS | 13,743.2 | GARZA O | 1 | 1 | MIKE S |  | 10-070 | 11-026 |  |  |  |  |  |  |  |  |  |  |  |  |  |  |  |  |  |  |  |  |  |  |
| 13614020 |  | FFB Sys Component & VME Testing |  | 40d | 2013-05-02 | 2013-06-27 | 13614014 | 65d |  |  | ELEC TECH [80 h]; COMP SCIENT [60 h]; ELEC ENG [60 h]; PROCUREMENT<$50K 60 | 15,817.11 | GARZA O | 1 | 1 | MIKE S |  | 10-070 | 11-026 |  |  |  |  |  |  |  |  |  |  |  |  |  |  |  |  |  |  |  |  |  |  |
| 13614950 |  | Re-Baseline Actuals Adjustment |  | 1d | 2013-08-30 | 2013-08-30 | 9-130M FS+227d | 20d |  |  | PROCUREMENT>$50K 69 NO ESCALATION | -141,294.4 | GARZA O | 1 | 1 | MIKE S |  |  |  | 13-014 | ADJ |  |  |  |  |  |  |  |  |  |  |  |  |  |  |  |  |  |  |  |  |
| 23614014 |  | FFB Sys Prcrmnts |  | 55d | 2014-03-05 | 2014-05-20 | 9-140M FS+100d | 49d | 0d | 8/5 M-F w/JLAB Holidays ReBaseline | ELEC TECH [51 h]; SUPPLIES & MATERIALS; PROCUREMENT<$50K 60 | 56,211.8 | GARZA O | 1 | 1 | MIKE S |  | 10-070 | 11-026 |  |  | 23614014 | EV | PE | PE | 13-015 | PR | 14-001 |  |  |  |  |  |  |  |  |  |  |  |  |  |
| 23614050LOE |  | FY14 Mngmnt Effort for FFB |  | 140d | 2014-03-05 | 2014-09-19 | 9-140M FS+100d | 50d | 1d | 8/5 M-F w/JLAB Holidays ReBaseline | SCIENTIST [17 h] | 1,278.06 | GARZA O | 1 | 1 | MIKE S |  |  |  |  |  | 23614050LOE |  | PE |  | 13-015 | PR | 14-001 | E |  |  |  |  |  |  |  |  |  |  |  |  |
| 23614015 |  | FFB Sys Fabriation & Assy |  | 43d | 2014-04-23 | 2014-06-23 | 23614014 FS-20d | 49d | 0d | 8/5 M-F w/JLAB Holidays ReBaseline | ELEC ENG [136 h]; PROCUREMENT<$50K 60; ELEC TECH [204 h]; ELEC DES [34 h]; SUPPLIES & MATERIALS | 27,064.66 | GARZA O | 1 | 1 | MIKE S |  | 10-070 | 11-026 |  |  | 23614015 | PE | PE | PE | 13-015 | PR | 14-001 |  |  |  |  |  |  |  |  |  |  |  |  |  |
| 23614020 |  | FFB Sys Component & VME Testing |  | 43d | 2014-04-23 | 2014-06-23 | 23614014 FS-20d | 112d | 63d | 8/5 M-F w/JLAB Holidays ReBaseline | ELEC TECH [68 h]; ELEC ENG [68 h]; PROCUREMENT<$50K 60 | 11,586.94 | GARZA O | 1 | 1 | MIKE S |  | 10-070 | 11-026 |  |  | 23614020 | PE | PE |  | 13-015 | PR | 14-001 |  |  |  |  |  |  |  |  |  |  |  |  |  |
| 23614030 |  | FFB Software Implementn |  | 48d | 2014-05-27 | 2014-08-01 | 23614025 FS-40d | 49d | 0d | 8/5 M-F w/JLAB Holidays ReBaseline | ELEC ENG [68 h]; COMP SCIENT [149.6 h]; ELEC TECH [68 h] | 18,756.71 | GARZA O | 1 | 1 | MIKE S |  | 10-070 | 11-026 |  |  | 23614030 |  | PE |  | 13-015 | PR | 14-001 |  | 10-031 | 12-005 | 12-026 |  |  |  |  |  |  |  |  |  |
| 23614025 |  | FFB Sys Hardware Implementn |  | 20d | 2014-06-24 | 2014-07-22 | 23614015, 23611035M | 49d | 0d | 8/5 M-F w/JLAB Holidays ReBaseline | SUPPLIES & MATERIALS; ELEC TECH [68 h] | 7,322.92 | GARZA O | 1 | 1 | MIKE S |  | 10-070 | 11-026 |  |  | 23614025 |  | PE | PE | 13-015 | PR | 14-001 |  |  | 12-005 | 12-026 |  |  |  |  |  |  |  |  |  |
| 23614035 |  | FFB Slow Lock Implementn |  | 30d | 2014-08-04 | 2014-09-15 | 23614030 | 49d | 0d | 8/5 M-F w/JLAB Holidays ReBaseline | COMP SCIENT [68 h] | 4,751.16 | GARZA O | 1 | 1 | MIKE S |  | 10-070 | 11-026 |  |  | 23614035 |  | PE |  | 13-015 | PR | 14-001 |  | 10-031 | 12-005 | 12-026 |  |  |  |  |  |  |  |  |  |
| 23614040 |  | FFB Slow Lock & FFB Cmmssng |  | 15d | 2014-09-02 | 2014-09-22 | 23614035 FS-10d, 32-05M, 23611035M | 49d | 0d | 8/5 M-F w/JLAB Holidays ReBaseline | COMP SCIENT [68 h]; ELEC TECH [17 h]; ELEC ENG [17 h] | 6,827.2 | GARZA O | 1 | 1 | MIKE S |  | 10-070 | 11-026 |  |  | 23614040 |  | PE |  | 13-015 | PR | 14-001 |  |  | 12-005 | 12-026 | 12-025 |  |  |  |  |  |  |  |  |
| 23614045M |  | FFB Sys Comp | milestone | 0d | 2014-09-22 | 2014-09-22 | 23614050LOE, 23614025, 23614020, 23614040 | 49d | 41d | 8/5 M-F w/JLAB Holidays ReBaseline |  |  | GARZA O | 1 | 1 | MIKE S |  | 10-070 | 11-026 |  |  | 23614045M |  |  |  | 13-015 | PR |  | M |  | 12-005 | 12-026 | 12-025 | 6 |  |  |  |  |  |  |  |
|  | 2 | **1.3.6.2 CONTROL SYSTEM HARDWARE** |  |  | 2009-01-02 | 2013-08-30 |  |  |  |  |  |  |  |  |  |  |  |  |  |  |  |  |  |  |  |  |  |  |  |  |  |  |  |  |  |  |  |  |  |  |  |
| 1362909LOE |  | FY09 CSH Sys Mngmnt Effort |  | 189d | 2009-01-02 | 2009-09-30 | 1362909LOEX | 20d | 0d |  | SR STAFF [3.05 h] | 313.66 | GARZA O | 1 | 1 | MIKE S | 08-058 |  |  |  |  |  |  |  |  |  |  |  |  |  |  |  |  |  |  |  |  |  |  |  |  |
| 1362910LOE |  | FY10 CSH Sys Mngmnt Effort |  | 248d | 2009-10-01 | 2010-09-30 | 1362909LOE | 20d | 0d |  | SR STAFF [4 h] | 424.48 | GARZA O | 1 | 1 | MIKE S |  |  |  |  |  |  |  |  |  |  |  |  |  |  |  |  |  |  |  |  |  |  |  |  |  |
| 1362014 |  | CSH Proc Compnts (multiple reqs) Linacs - Labor |  | 40d | 2010-04-01 | 2010-05-26 | 9-100M FS+120d, 12162040M | 451d | 0d |  | ELEC ENG [20 h]; ELEC TECH [40 h] | 2,983.4 | GARZA O | 1 | 1 | MIKE S |  |  |  |  |  |  |  |  |  |  |  |  |  | 10-031 |  |  |  |  | 12-018F | 12-037F |  |  |  |  |  |
| 1362014A |  | CSH Proc Compnts (multiple reqs) Linacs - Procurements |  | 40d | 2010-04-01 | 2010-05-26 | 9-100M FS+120d | 451d | 0d |  | PROCUREMENT<$50K 60; PROCUREMENT>$50K 69 | 119,218.21 | GARZA O | 1 | 1 | MIKE S |  |  |  |  |  |  |  |  |  |  |  |  |  | 10-031 |  |  |  |  | 12-018F | 12-037F |  |  |  |  |  |
| 1362910ALOE |  | FY10 Engineering Oversight |  | 128d | 2010-04-01 | 2010-09-30 | 9-100M FS+120d | 20d | 0d |  | ELEC ENG [150.8 h] | 9,993.52 | GARZA O | 1 | 1 | MIKE S |  |  |  |  |  |  |  |  |  |  |  |  |  | 10-031 |  |  |  |  |  |  |  |  |  |  |  |
| 1362015 |  | CSH Hardware Setup/Configuration Linacs - Labor FY10 |  | 88d | 2010-05-27 | 2010-09-30 | 1362014, 1362014A | 451d | 0d |  | ELEC TECH [150.86 h]; TRAVEL; ELEC ENG [50.29 h] | 12,079.17 | GARZA O | 1 | 1 | MIKE S |  |  |  |  |  |  |  |  |  |  |  |  |  | 10-031 |  |  |  |  | 12-018F | 12-037F | 11-001 |  |  |  |  |
| 1362015A |  | CSH Hardware Setup/Configuration Linacs - Procurement |  | 140d | 2010-05-27 | 2010-12-15 | 1362014A, 1362014 | 451d | 0d |  | PROCUREMENT<$50K 60 NO ESCALATION FY11 | 7,691.5 | GARZA O | 1 | 1 | MIKE S |  |  |  |  |  |  |  |  |  |  |  |  |  | 10-031 |  |  |  |  | 12-018F | 12-037F |  |  |  |  |  |
| 1362015ab |  | CSH Hardware Setup/Configuration Linacs - Labor FY11 |  | 52d | 2010-10-01 | 2010-12-15 | 1362015 | 451d | 0d |  | ELEC TECH [89.14 h]; TRAVEL; ELEC ENG [29.71 h] | 7,364.41 | GARZA O | 1 | 1 | MIKE S |  |  |  |  |  |  |  |  |  |  |  |  |  | 10-031 |  |  |  |  | 12-018F | 12-037F | 11-001 |  |  |  |  |
| 1362911LOE |  | FY11 CSH Sys Mngmnt Effort (Including Engineering Oversight) |  | 248d | 2010-10-01 | 2011-09-30 | 1362910ALOE, 1362910LOE | 20d | 0d |  | SR STAFF [60 h]; ELEC ENG [150.8 h] | 16,882.3 | GARZA O | 1 | 1 | MIKE S |  |  |  |  |  |  |  |  |  |  |  |  |  | 10-031 |  |  |  |  |  |  |  |  |  |  |  |
| 1362020 |  | CSH Installtn Network/Controls Linacs - Labor |  | 40d | 2010-12-16 | 2011-02-18 | 1362015ab, 1362015A | 451d | 0d |  | PLABOR; ELEC DES [40 h]; ELEC TECH [120 h] | 8,990.72 | GARZA O | 1 | 1 | MIKE S |  |  |  |  |  |  |  |  |  |  |  |  |  | 10-031 |  |  |  |  | 12-018F | 12-037F |  | 08-016 | 09-012 |  |  |
| 1362020A |  | CSH Installtn Network/Controls Linacs - Procurement |  | 40d | 2010-12-16 | 2011-02-18 | 1362015ab, 1362015A | 451d | 0d |  | PROCUREMENT<$50K 60 | 10,204.53 | GARZA O | 1 | 1 | MIKE S |  |  |  |  |  |  |  |  |  |  |  |  |  | 10-031 |  |  |  |  | 12-018F |  |  |  |  |  |  |
| 1362025 |  | CSH Commisioning Network/Controls Linacs |  | 70d | 2011-02-22 | 2011-05-31 | 1362020A, 1362020 | 451d | 113d |  | ELEC ENG [40 h]; ELEC TECH [140 h]; COMP SCIENT [80 h] | 13,810.2 | GARZA O | 1 | 1 | MIKE S |  |  |  |  |  |  |  |  |  |  |  |  |  | 10-031 |  |  |  |  | 12-018F |  |  |  |  |  |  |
| 1362014B |  | CSH Proc Compnts (multiple reqs) Tagger Service Building - Labor |  | 40d | 2011-10-03 | 2011-11-29 | 9-120M | 105d | 0d |  | ELEC TECH [40 h]; ELEC ENG [20 h] | 3,176.4 | GARZA O | 1 | 1 | MIKE S |  | 10-070 |  |  |  |  |  |  |  |  |  |  |  | 10-031 |  |  |  |  |  |  |  |  |  |  |  |
| 1362014C |  | CSH Proc Compnts (multiple reqs) Tagger Service Building - Procurements |  | 40d | 2011-10-03 | 2011-11-29 | 9-120M | 105d | 0d |  | PROCUREMENT>$50K 69; PROCUREMENT<$50K 60 | 126,945.64 | GARZA O | 1 | 1 | MIKE S |  | 10-070 |  |  |  |  |  |  |  |  |  |  |  | 10-031 |  |  |  |  |  |  |  |  |  |  |  |
| 1362912LOE |  | FY12 CSH Sys Mngmnt Effort (Including Engineering Oversight) |  | 247d | 2011-10-03 | 2012-09-28 | 1362911LOE | 20d | 0d |  | ELEC ENG [150.8 h]; SR STAFF [60 h] | 17,420.45 | GARZA O | 1 | 1 | MIKE S |  |  |  |  |  |  |  |  |  |  |  |  |  | 10-031 |  |  |  |  |  |  |  |  |  |  |  |
| 1362015B |  | CSH Hardware Setup/Configuration Tagger Service Building - Labor |  | 140d | 2011-11-30 | 2012-06-26 | 1362014B, 1362014C | 105d | 0d |  | ELEC ENG [80 h]; ELEC TECH [240 h]; TRAVEL | 20,459.71 | GARZA O | 1 | 1 | MIKE S |  | 10-070 |  |  |  |  |  |  |  |  |  |  |  | 10-031 |  |  |  |  |  |  |  |  |  |  |  |
| 1362015C |  | CSH Hardware Setup/Configuration Tagger Service Building - Procurement |  | 140d | 2011-11-30 | 2012-06-26 | 1362014B, 1362014C | 105d | 0d |  | PROCUREMENT<$50K 60 | 8,190.05 | GARZA O | 1 | 1 | MIKE S |  | 10-070 |  |  |  |  |  |  |  |  |  |  |  | 10-031 |  |  |  |  |  |  |  |  |  |  |  |
| 1362020B |  | CSH Installtn Network/Controls Tagger Service Building - Labor |  | 40d | 2012-06-27 | 2012-08-21 | 1362015B, 1362015C | 105d | 0d |  | ELEC TECH [120 h]; PLABOR; ELEC DES [40 h] | 9,276.93 | GARZA O | 1 | 1 | MIKE S |  | 10-070 |  |  |  |  |  |  |  |  |  |  |  | 10-031 |  |  |  |  |  |  |  |  |  |  |  |
| 1362020C |  | CSH Installtn Network/Controls Tagger Service Building - Procurement |  | 40d | 2012-06-27 | 2012-08-21 | 1362015C, 1362015B | 105d | 0d |  | PROCUREMENT<$50K 60 | 10,530.05 | GARZA O | 1 | 1 | MIKE S |  | 10-070 |  |  |  |  |  |  |  |  |  |  |  | 10-031 |  |  |  |  |  |  |  |  |  |  |  |
| 1362025A |  | CSH Commisioning Network/Controls Tagger Service Building FY12 |  | 27d | 2012-08-22 | 2012-09-28 | 1362020B, 1362020C | 105d | 0d |  | ELEC ENG [15.43 h]; ELEC TECH [54 h]; COMP SCIENT [30.86 h] | 5,496.79 | GARZA O | 1 | 1 | MIKE S |  | 10-070 |  |  |  |  |  |  |  |  |  |  |  | 10-031 |  |  |  |  |  |  |  |  |  | 12-053 |  |
| 1362025Aa |  | CSH Commisioning Network/Controls Tagger Service Building FY13 |  | 43d | 2012-10-01 | 2012-11-30 | 1362025A | 105d | 0d |  | ELEC ENG [24.57 h]; ELEC TECH [86 h]; COMP SCIENT [49.14 h] | 9,032.65 | GARZA O | 1 | 1 | MIKE S |  | 10-070 |  |  |  |  |  |  |  |  |  |  |  | 10-031 |  |  |  |  |  |  |  |  |  | 12-053 |  |
| 1362026 |  | East Arc 12Gev Network Upgrade Procuremnts |  | 100d | 2012-12-03 | 2013-05-01 | 1362025, 1362025Aa | 105d | 0d |  | PROCUREMENT<$50K 60; ELEC ENG [16 h]; ELEC TECH [40 h] | 14,986.56 | GARZA O | 1 | 1 | MIKE S |  | 10-070 |  |  |  |  |  |  |  |  |  |  |  | 10-031 |  |  |  |  |  |  |  | 08-016 | 09-012 |  | 13-003 |
| 1362027 |  | East Arc 12Gev Network Upgrade Installations |  | 100d | 2012-12-03 | 2013-05-01 | 1362025Aa, 1362025 | 105d | 0d |  | PROCUREMENT<$50K 60; ELEC TECH [200 h]; ELEC ENG [16 h] | 12,272.96 | GARZA O | 1 | 1 | MIKE S |  | 10-070 |  |  |  |  |  |  |  |  |  |  |  | 10-031 |  |  |  |  |  |  |  | 08-016 | 09-012 |  | 13-003 |
| 1362028 |  | East Arc 12Gev Network Upgrade Testing |  | 100d | 2012-12-03 | 2013-05-01 | 1362025Aa, 1362025 | 105d | 0d |  | ELEC TECH [80 h] | 3,643.2 | GARZA O | 1 | 1 | MIKE S |  | 10-070 |  |  |  |  |  |  |  |  |  |  |  | 10-031 |  |  |  |  |  |  |  | 08-016 | 09-012 |  | 13-003 |
| 1362030 |  | CSH Gateway , Data Storage, CPU Capacity |  | 100d | 2012-12-03 | 2013-05-01 | 1362025Aa, 1362025 | 105d | 0d |  | COMP SCIENT [160 h]; TRAVEL; PROCUREMENT<$50K 60 | 87,658.4 | GARZA O | 1 | 1 | MIKE S |  | 10-070 |  |  |  |  |  |  |  |  |  |  |  | 10-031 |  |  |  |  |  |  |  | 08-016 | 09-012 |  | 13-003 |
| 1362035M |  | CSH Comp Milestone | milestone | 0d | 2013-05-01 | 2013-05-01 | 1362026, 1362027, 1362028, 1362030, 1362025 | 105d |  |  |  |  | GARZA O | 1 | 1 | MIKE S |  | 10-070 |  |  |  |  |  |  |  |  |  |  |  | 10-031 |  |  |  | 6 |  |  |  |  |  |  |  |
| 1362950 |  | Re-Baseline Actuals Adjustment |  | 1d | 2013-08-30 | 2013-08-30 | 9-130M FS+227d | 20d |  |  | PROCUREMENT>$50K 69 NO ESCALATION | -74,543.5 | GARZA O | 1 | 1 | MIKE S |  |  |  | 13-014 | ADJ |  |  |  |  |  |  |  |  |  |  |  |  |  |  |  |  |  |  |  |  |

Notes:
- 23614025: Entry Criteria: Ext Pred: Correctors, BPMs, RF, / IOCs, network installed
- 23614040: Entry Criteria: Required predecessor: Beam / Ext Pred: Correctors, BPMs, RF, IOCs, network beam / sync functioning
- 1362020: Entry Criteria: Ext Pred: BOD new service / building
- 1362020A: Entry Criteria: Ext Pred: BOD new service / building
- 1362020B: Entry Criteria: Ext Pred: BOD new service / building
- 1362020C: Entry Criteria: Ext Pred: BOD new service / building

| ID | WBS | Activity | Duration | Start | Finish | Predecessors | Total float | Free float | Calendar | Resources | Cost | RESP - Responsibility | STRT%COMP for CM EVM | FNSH%COMP for CM EVM | CAM RESPONSIBLE | CR 08-058 | CR 08-016 | CR 08-052 | CR 09-012 | CR 10-070 | CR 11-038 | CR 12-029 | CR 12-053 | CR 11-026 | CR 12-018 | CR 12-035 | CR 10-031 | CR 10-064 | CR 13-014 | ReBaseline Actuals Adjustment | Original Activity ID Rebaseline | BOE Labor | BOE Adder | CR 13-015 | Post Rebaseline |
| --- | --- | --- | --- | --- | --- | --- | --- | --- | --- | --- | --- | --- | --- | --- | --- | --- | --- | --- | --- | --- | --- | --- | --- | --- | --- | --- | --- | --- | --- | --- | --- | --- | --- | --- | --- |
|  | 3 | **1.3.6.3 CONTROL SYSTEM SOFTWARE** |  | 2009-01-02 | 2013-09-30 |  |  |  |  |  |  |  |  |  |  |  |  |  |  |  |  |  |  |  |  |  |  |  |  |  |  |  |  |  |  |
| 1363909LOE |  | FY09 CSS Sys Mngmnt Effort | 189d | 2009-01-02 | 2009-09-30 | 1363909LOEX | 20d | 0d |  | SR STAFF [18.29 h] | 1,880.94 | BICKLEY M | 1 | 1 | MIKE S | 08-058 |  |  |  |  |  |  |  |  |  |  |  |  |  |  |  |  |  |  |  |
| 1363910LOE |  | FY10 CSS Sys Mngmnt Effort | 248d | 2009-10-01 | 2010-09-30 | 1363909LOE | 20d | 0d |  | SR STAFF [24 h] | 2,546.88 | BICKLEY M | 1 | 1 | MIKE S |  |  |  |  |  |  |  |  |  |  |  |  |  |  |  |  |  |  |  |  |
| 1363911LOE |  | FY11 CSS Sys Mngmnt Effort | 248d | 2010-10-01 | 2011-09-30 | 1363910LOE | 20d | 0d |  | SR STAFF [24 h] | 2,628.24 | BICKLEY M | 1 | 1 | MIKE S |  |  |  |  |  |  |  |  |  |  |  |  |  |  |  |  |  |  |  |  |
| 1363015 |  | Update Hi-Level Applications Labor FY11 | 108d | 2011-04-29 | 2011-09-30 | 9-110M FS+140d | 160d | 0d |  | COMP SCIENT [527.5 h] | 33,543.73 | BICKLEY M | 1 | 1 | MIKE S |  | 08-016 | 08-052 | 09-012 | 10-070 | 11-038 | 12-029F |  |  |  |  |  |  |  |  |  |  |  |  |  |
| 1363015b |  | Update Hi-Level Applications Procurement | 475d | 2011-04-29 | 2013-03-29 | 9-110M FS+140d | 160d |  |  | PROCUREMENT<$50K 60 NO ESCALATION FY12 | 5,850.59 | BICKLEY M | 1 | 1 | MIKE S |  | 08-016 | 08-052 | 09-012 | 10-070 | 11-038 | 12-029F |  |  |  |  |  |  |  |  |  |  |  |  |  |
| 1363015a |  | Update Hi-Level Applications Labor FY12 | 247d | 2011-10-03 | 2012-09-28 | 1363015 | 160d | 0d |  | COMP SCIENT [1206.4 h] | 79,163.97 | BICKLEY M | 1 | 1 | MIKE S |  | 08-016 | 08-052 | 09-012 | 10-070 | 11-038 | 12-029F | 12-053 |  |  |  |  |  |  |  |  |  |  |  |  |
| 1363912LOE |  | FY12 CSS Sys Mngmnt Effort | 247d | 2011-10-03 | 2012-09-28 | 1363911LOE | 20d | 0d |  | SR STAFF [24 h] | 2,712 | BICKLEY M | 1 | 1 | MIKE S |  |  |  |  |  |  |  |  |  |  |  |  |  |  |  |  |  |  |  |  |
| 1363020 |  | Update Sys Tools (CONT SYS SW) FY12 | 107d | 2012-04-30 | 2012-09-28 | 9-120M FS+140d | 320d | 0d |  | COMP SCIENT [440.97 h] | 28,936.45 | BICKLEY M | 1 | 1 | MIKE S |  | 08-016 |  | 09-012 | 10-070 |  | 12-029F | 12-053 | 11-026 | 12-018F | 12-035F |  |  |  |  |  |  |  |  |  |
| 1363020b |  | Update Sys Tools (CONT SYS SW) Procurement | 165d | 2012-04-30 | 2012-12-21 | 9-120M FS+140d | 320d | 275d |  | PROCUREMENT<$50K 60 NO ESCALATION FY13 | 11,840.45 | BICKLEY M | 1 | 1 | MIKE S |  | 08-016 |  | 09-012 | 10-070 |  | 12-029F | 12-053 | 11-026 | 12-018F | 12-035F |  |  |  |  |  |  |  |  |  |
| 1363025 |  | Update Low-Level Applications (CONT SYS SW) FY12 | 107d | 2012-04-30 | 2012-09-28 | 9-120M FS+140d | 180d | 0d |  | COMP SCIENT [254.49 h]; SUPPLIES & MATERIALS | 21,165.9 | BICKLEY M | 1 | 1 | MIKE S |  |  |  |  | 10-070 |  |  | 12-053 |  |  |  | 10-031 | 10-064 |  |  |  |  |  |  |  |
| 1363025b |  | Update Low-Level Applications (CONT SYS SW) Procurement | 185d | 2012-04-30 | 2013-01-29 | 9-120M FS+140d | 180d |  |  | PROCUREMENT<$50K 60 NO ESCALATION FY13 | 19,316.81 | BICKLEY M | 1 | 1 | MIKE S |  |  |  |  | 10-070 |  |  | 12-053 |  |  |  | 10-031 | 10-064 |  |  |  |  |  |  |  |
| 1363014 |  | Update Synoptic Displays (CONT SYS SW) FY12 | 97d | 2012-05-14 | 2012-09-28 | 2-02M | 205d | 0d |  | COMP SCIENT [517.33 h] | 33,947.19 | BICKLEY M | 1 | 1 | MIKE S |  |  |  |  |  |  |  | 12-053 |  |  |  |  |  |  |  |  |  |  |  |  |
| 1363035 |  | Integration with Sys administration Mngmnt Software (CONT SYS SW) | 20d | 2012-05-14 | 2012-06-12 | 2-02M | 335d | 162d |  | COMP SCIENT [80 h]; SUPPLIES & MATERIALS | 14,913.84 | BICKLEY M | 1 | 1 | MIKE S |  |  |  |  |  |  | 12-029F |  | 11-026 | 12-018F | 12-035F | 10-031 |  |  |  |  |  |  |  |  |
| 1363030 |  | Update Communication/Coordination Tools (CONT SYS SW) FY12 | 17d | 2012-09-06 | 2012-09-28 | 9-120M FS+230d, 12163050M | 180d | 0d |  | COMP SCIENT [40 h] | 2,624.8 | BICKLEY M | 1 | 1 | MIKE S |  |  |  |  | 10-070 |  |  | 12-053 |  |  |  |  |  |  |  |  |  |  |  |  |
| 1363014a |  | Update Synoptic Displays (CONT SYS SW) FY13 | 53d | 2012-10-01 | 2012-12-14 | 1363014 | 205d |  |  | COMP SCIENT [282.67 h] | 19,139.59 | BICKLEY M | 1 | 1 | MIKE S |  |  |  |  |  |  |  | 12-053 |  |  |  |  |  |  |  |  |  |  |  |  |
| 1363015aa |  | Update Hi-Level Applications Labor FY13 | 120d | 2012-10-01 | 2013-03-29 | 1363015a | 160d |  |  | COMP SCIENT [586.1 h] | 39,684.83 | BICKLEY M | 1 | 1 | MIKE S |  | 08-016 | 08-052 | 09-012 | 10-070 | 11-038 | 12-029F | 12-053 |  |  |  |  |  |  |  |  |  |  |  |  |
| 1363020a |  | Update Sys Tools (CONT SYS SW) FY13 | 58d | 2012-10-01 | 2012-12-21 | 1363020 | 320d | 275d |  | COMP SCIENT [239.03 h] | 16,184.72 | BICKLEY M | 1 | 1 | MIKE S |  | 08-016 |  | 09-012 | 10-070 |  | 12-029F | 12-053 | 11-026 | 12-018F | 12-035F |  |  |  |  |  |  |  |  |  |
| 1363025a |  | Update Low-Level Applications (CONT SYS SW) FY13 | 78d | 2012-10-01 | 2013-01-29 | 1363025 | 180d |  |  | COMP SCIENT [185.51 h]; SUPPLIES & MATERIALS | 15,920.52 | BICKLEY M | 1 | 1 | MIKE S |  |  |  |  | 10-070 |  |  | 12-053 |  |  |  | 10-031 | 10-064 |  |  |  |  |  |  |  |
| 1363030a |  | Update Communication/Coordination Tools (CONT SYS SW) FY13 | 68d | 2012-10-01 | 2013-01-14 | 1363030 | 180d |  |  | COMP SCIENT [160 h] | 10,833.6 | BICKLEY M | 1 | 1 | MIKE S |  |  |  |  | 10-070 |  |  | 12-053 |  |  |  |  |  |  |  |  |  |  |  |  |
| 1363913LOE |  | FY13 CSS Sys Mngmnt Effort | 228d | 2012-10-01 | 2013-08-30 | 1363912LOE | 20d |  |  | SR STAFF [22.06 h] | 2,572.2 | BICKLEY M | 1 | 1 | MIKE S |  |  |  |  |  |  |  |  |  |  |  |  |  | 13-014 |  |  |  |  |  |  |
| 1363950 |  | Re-Baseline Actuals Adjustment | 1d | 2013-08-30 | 2013-08-30 | 9-130M FS+227d | 20d |  |  | PROCUREMENT>$50K 69 NO ESCALATION | -60,622.95 | BICKLEY M | 1 | 1 | MIKE S |  |  |  |  |  |  |  |  |  |  |  |  |  | 13-014 | ADJ |  |  |  |  |  |
| 2363015aa |  | Update Hi-Level Applications Labor | 20d | 2013-09-03 | 2013-09-30 | 9-130M FS+228d | 32d |  | 8/5 M-F w/JLAB Holidays ReBaseline | COMP SCIENT [296.2 h] | 20,055.7 | BICKLEY M | 1 | 1 | MIKE S |  | 08-016 | 08-052 | 09-012 | 10-070 | 11-038 | 12-029F | 12-053 |  |  |  |  |  |  |  | 2363015aa | PE | NO | 13-015 | PR |
| 2363913LOE |  | FY13 CSS Sys Mngmnt Effort | 20d | 2013-09-03 | 2013-09-30 | 9-130M FS+228d | 89d |  | 8/5 M-F w/JLAB Holidays ReBaseline | SR STAFF [1.93 h] | 225.04 | BICKLEY M | 1 | 1 | MIKE S |  |  |  |  |  |  |  |  |  |  |  |  |  |  |  | 2363913LOE | PE |  | 13-015 | PR |

Notes:
- 1363015: Entry Criteria: Ext Pred: Beamline design / finalized
- 1363015b: Entry Criteria: Ext Pred: Beamline design / finalized
- 1363015a: Entry Criteria: Ext Pred: Beamline design / finalized
- 1363025: Corrective Actions: pred of beamline final / designed
- 1363025b: Corrective Actions: pred of beamline final / designed
- 1363014: Corrective Actions: Review Potential Successors
- 1363014a: Corrective Actions: Review Potential Successors
- 1363015aa: Entry Criteria: Ext Pred: Beamline design / finalized
- 1363025a: Corrective Actions: pred of beamline final / designed
- 2363015aa: Entry Criteria: Ext Pred: Beamline design / finalized

| ID | WBS | Activity | Type | Duration | Start | Finish | Predecessors | Total float | Free float | Calendar | Resources | Cost | RESP - Responsibility | STRT%COMP for CM EVM | FNSH%COMP for CM EVM | CAM RESPONSIBLE | CR 08-058 | CR 10-031 | CR 12-037 | CR 12-001 | CR 10-065 | CR 09-015 | CR 12-053 | CR 13-014 | CR 13-003 | Milestone Level | ReBaseline Actuals Adjustment | Original Activity ID Rebaseline | EVMS Reporting Codes | Activities with Steps | BOE Labor | BOE Adder | CR 13-015 | Post Rebaseline | Over Under Fixed | Obligated Prior to Rebaseline | CR 14-001 |
| --- | --- | --- | --- | --- | --- | --- | --- | --- | --- | --- | --- | --- | --- | --- | --- | --- | --- | --- | --- | --- | --- | --- | --- | --- | --- | --- | --- | --- | --- | --- | --- | --- | --- | --- | --- | --- | --- |
|  | 4 | **1.3.6.4 SAFETY SYSTEMS** |  |  | 2009-01-02 | 2014-06-02 |  |  |  |  |  |  |  |  |  |  |  |  |  |  |  |  |  |  |  |  |  |  |  |  |  |  |  |  |  |  |  |
|  | 1 | **1.3.6.4.1 MACHINE PROTECTION** |  |  | 2009-01-02 | 2014-06-02 |  |  |  |  |  |  |  |  |  |  |  |  |  |  |  |  |  |  |  |  |  |  |  |  |  |  |  |  |  |  |  |
| 13641909LOE |  | FY09 Mngmnt & Elect Dsgn Supprt Effort for MPS |  | 189d | 2009-01-02 | 2009-09-30 | 13641909LOEX | 20d | 0d |  | ELEC DES [3.05 h]; SR STAFF [3.05 h] | 453.9 | MAHONEY K | 1 | 1 | MIKE S | 08-058 |  |  |  |  |  |  |  |  |  |  |  |  |  |  |  |  |  |  |  |  |
| 13641910LOE |  | FY10 Mngmnt & Elect Dsgn Supprt Effort for MPS |  | 248d | 2009-10-01 | 2010-09-30 | 13641909LOE | 20d | 0d |  | SR STAFF [4 h]; ELEC DES [4 h] | 614.24 | MAHONEY K | 1 | 1 | MIKE S |  |  |  |  |  |  |  |  |  |  |  |  |  |  |  |  |  |  |  |  |  |
| 13641911LOE |  | FY11 Mngmnt & Elect Dsgn Supprt Effort for MPS |  | 248d | 2010-10-01 | 2011-09-30 | 13641910LOE | 20d | 0d |  | SR STAFF [36 h]; ELEC DES [64 h] | 7,075.16 | MAHONEY K | 1 | 1 | MIKE S |  |  |  |  |  |  |  |  |  |  |  |  |  |  |  |  |  |  |  |  |  |
| 13641014a |  | Proc Wire & Cable for RF Installation (MPS) |  | 50d | 2011-01-05 | 2011-03-17 | 9-110M FS+60d | 540d | 0d |  | ELEC TECH [18 h]; ELEC ENG [20 h]; PROCUREMENT<$50K 60 | 3,685.31 | MAHONEY K | 1 | 1 | MIKE S |  | 10-031 | 12-037F |  |  |  |  |  |  |  |  |  |  |  |  |  |  |  |  |  |  |
| 13641015a |  | Proc FSD Hardware for RF Installation (MPS) |  | 40d | 2011-03-18 | 2011-05-12 | 13641014a | 540d | 0d |  | ELEC TECH [18 h]; PROCUREMENT<$50K 60; ELEC ENG [20 h] | 5,336.35 | MAHONEY K | 1 | 1 | MIKE S |  | 10-031 | 12-037F |  |  |  |  |  |  |  |  |  |  |  |  |  |  |  |  |  |  |
| 13641020a |  | Test/QA FSD Hardware for RF Installation (MPS) |  | 30d | 2011-05-13 | 2011-06-24 | 13641015a | 540d | 0d |  | ELEC ENG [40 h]; ELEC TECH [96 h] | 6,841.12 | MAHONEY K | 1 | 1 | MIKE S |  | 10-031 | 12-037F |  |  |  |  |  |  |  |  |  |  |  |  |  |  |  |  |  |  |
| 13641025a |  | Install FSD Wire & Cable for RF Installation (MPS) FY11 |  | 68d | 2011-06-27 | 2011-09-30 | 13641020a | 540d | 0d |  | ELEC TECH [31.73 h]; PLABOR; ELEC ENG [5.44 h] | 1,962.98 | MAHONEY K | 1 | 1 | MIKE S |  | 10-031 | 12-037F | 12-001 |  |  |  |  |  |  |  |  |  |  |  |  |  |  |  |  |  |
| 13641025ab |  | Install FSD Wire & Cable for RF Installation (MPS) FY12 |  | 82d | 2011-10-03 | 2012-02-06 | 13641025a | 540d | 0d |  | ELEC TECH [38.27 h]; PLABOR; ELEC ENG [6.56 h] | 2,442.78 | MAHONEY K | 1 | 1 | MIKE S |  | 10-031 | 12-037F | 12-001 |  |  |  |  |  |  |  |  |  |  |  |  |  |  |  |  |  |
| 13641912LOE |  | FY12 Mngmnt & Elect Dsgn Supprt Effort for MPS |  | 247d | 2011-10-03 | 2012-09-28 | 13641911LOE | 20d | 0d |  | ELEC DES [64 h]; SR STAFF [36 h] | 7,300.64 | MAHONEY K | 1 | 1 | MIKE S |  |  |  |  |  |  |  |  |  |  |  |  |  |  |  |  |  |  |  |  |  |
| 13641014 |  | Proc Wire & Cable (MPS) |  | 50d | 2012-01-05 | 2012-03-16 | 121641110M, 9-120M FS+60d, 121641170 | 30d | 0d |  | PROCUREMENT<$50K 60; ELEC TECH [20.77 h]; ELEC ENG [20.77 h] | 43,045.49 | MAHONEY K | 1 | 1 | MIKE S |  | 10-031 | 12-037F |  |  |  |  |  |  |  |  |  |  |  |  |  |  |  |  |  |  |
| 13641050 |  | Proc BLM Hardware (MPS) |  | 40d | 2012-01-05 | 2012-03-02 | 9-120M FS+60d | 347d | 0d |  | ELEC ENG [40 h]; PROCUREMENT<$50K 60; ELEC TECH [80 h] | 48,976.12 | MAHONEY K | 1 | 1 | MIKE S |  |  | 12-037F |  | 10-065 |  |  |  |  |  |  |  |  |  |  |  |  |  |  |  |  |
| 13641085 |  | Proc Tagger/Hall D Beam Loss Monitoring Hardware (MPS) |  | 50d | 2012-01-05 | 2012-03-16 | 9-120M FS+60d | 480d | 0d |  | ELEC TECH [40 h]; PROCUREMENT<$50K 60; ELEC ENG [40 h] | 31,837.48 | MAHONEY K | 1 | 1 | MIKE S |  |  | 12-037F |  |  | 09-015 |  |  |  |  |  |  |  |  |  |  |  |  |  |  |  |
| 13641030a |  | Install/Test FSD Hardwarefor RF Installation(MPS) |  | 30d | 2012-02-07 | 2012-03-20 | 13641025ab | 540d | 193d |  | ELEC TECH [32 h]; ELEC ENG [16 h] | 2,541.12 | MAHONEY K | 1 | 1 | MIKE S |  | 10-031 | 12-037F |  |  |  |  |  |  |  |  |  |  |  |  |  |  |  |  |  |  |
| 13641055 |  | Test/QA BLM Hardware (MPS) |  | 30d | 2012-03-05 | 2012-04-13 | 13641050 | 459d | 207d |  | ELEC ENG [40 h]; ELEC TECH [80 h] | 6,352.8 | MAHONEY K | 1 | 1 | MIKE S |  |  | 12-037F |  |  |  |  |  |  |  |  |  |  |  |  |  |  |  |  |  |  |
| 13641015 |  | Proc FSD Hardware (MPS) |  | 40d | 2012-03-19 | 2012-05-11 | 13641014, 121641110M, 121641170 | 347d | 0d |  | ELEC TECH [20.77 h]; PROCUREMENT<$50K 60; ELEC ENG [20.77 h] | 13,565.84 | MAHONEY K | 1 | 1 | MIKE S |  | 10-031 | 12-037F |  |  |  |  |  |  |  |  |  |  |  |  |  |  |  |  |  |  |
| 13641025 |  | Install FSD Wire & Cable (MPS) FY12 |  | 137d | 2012-03-19 | 2012-09-28 | 3A-08M, 16332030, 16332010U, 13641014 | 352d | 0d |  | ELEC TECH [154.88 h]; PLABOR; ELEC ENG [25.81 h] | 13,162.26 | MAHONEY K | 1 | 1 | MIKE S |  | 10-031 | 12-037F |  |  |  | 12-053 |  |  |  |  |  |  |  |  |  |  |  |  |  |  |
| 13641090 |  | Test/QA Tagger/Hall D Beam Loss Monitoring Hardware (MPS) |  | 20d | 2012-03-19 | 2012-04-13 | 13641085 | 480d | 184d |  | ELEC ENG [40 h]; ELEC TECH [80 h] | 6,352.8 | MAHONEY K | 1 | 1 | MIKE S |  |  | 12-037F |  |  | 09-015 |  |  |  |  |  |  |  |  |  |  |  |  |  |  |  |
| 13641020 |  | Test/QA FSD Hardware (MPS) FY12 |  | 21d | 2012-08-30 | 2012-09-28 | 13641015 FS+76d | 347d | 0d |  | ELEC ENG [14.19 h]; ELEC TECH [21.29 h] | 1,940.78 | MAHONEY K | 1 | 1 | MIKE S |  | 10-031 | 12-037 |  |  |  | 12-053 |  |  |  |  |  |  |  |  |  |  |  |  |  |  |
| 13641020b |  | Test/QA FSD Hardware (MPS) FY13 |  | 21d | 2012-10-01 | 2012-10-29 | 13641020 | 347d | 0d |  | ELEC TECH [21.29 h]; ELEC ENG [14.19 h] | 2,002.72 | MAHONEY K | 1 | 1 | MIKE S |  | 10-031 | 12-037 |  |  |  | 12-053 |  |  |  |  |  |  |  |  |  |  |  |  |  |  |
| 13641025b |  | Install FSD Wire & Cable (MPS) FY13 |  | 13d | 2012-10-01 | 2012-10-17 | 13641025 | 352d | 0d |  | ELEC ENG [2.45 h]; ELEC TECH [14.7 h]; PLABOR | 1,289.06 | MAHONEY K | 1 | 1 | MIKE S |  | 10-031 | 12-037F |  |  |  | 12-053 |  |  |  |  |  |  |  |  |  |  |  |  |  |  |
| 13641913LOE |  | FY13 Mngmnt & Elect Dsgn Supprt Effort for MPS |  | 228d | 2012-10-01 | 2013-08-30 | 13641912LOE | 20d |  |  | ELEC DES [58.84 h]; SR STAFF [33.1 h] | 6,926.09 | MAHONEY K | 1 | 1 | MIKE S |  |  |  |  |  |  |  | 13-014 |  |  |  |  |  |  |  |  |  |  |  |  |  |
| 13641035 |  | Develop/Install/Test FSD Firmware (MPS) |  | 40d | 2012-10-18 | 2012-12-14 | 13641025b, 13641030 FS-45d | 352d | 5d |  | ELEC ENG [200 h] | 14,562 | MAHONEY K | 1 | 1 | MIKE S |  |  | 12-037F |  |  |  |  |  |  |  |  |  |  |  |  |  |  |  |  |  |  |
| 13641014b |  | Proc Remaining Wire & Cable (MPS) |  | 10d | 2012-11-01 | 2012-11-14 | 9-130M FS+23d | 372d | 120d |  | PROCUREMENT<$50K 60 | 8,100 | MAHONEY K | 1 | 1 | MIKE S |  | 10-031 | 12-037F |  |  |  |  |  | 13-003 |  |  |  |  |  |  |  |  |  |  |  |  |
| 13641030 |  | Install/Test FSD Hardware (MPS) |  | 35d | 2012-11-01 | 2012-12-21 | 1362020, 16332030, 13641020b FS+2d | 347d | 0d |  | ELEC ENG [64 h]; ELEC TECH [128 h] | 10,488.96 | MAHONEY K | 1 | 1 | MIKE S |  | 10-031 | 12-037 |  |  |  |  |  |  |  |  |  |  |  |  |  |  |  |  |  |  |
| 13641060 |  | Install BLM Wire & Cable (MPS) |  | 35d | 2012-11-01 | 2012-12-21 | 16333030 FS-125d, 13641050 FS+170d, 16332030, 16332010U | 347d | 95d |  | PLABOR; ELEC TECH [320 h]; ELEC ENG [80 h] | 31,677.67 | MAHONEY K | 1 | 1 | MIKE S |  |  | 12-037 |  |  |  |  |  |  |  |  |  |  |  |  |  |  |  |  |  |  |
| 13641070 |  | Develop/Install/Test BLM Firmware (MPS) |  | 35d | 2012-11-01 | 2012-12-21 | 13641065 FS-87d | 347d | 95d |  | ELEC ENG [160 h] | 11,649.6 | MAHONEY K | 1 | 1 | MIKE S |  |  | 12-037 |  |  |  |  |  |  |  |  |  |  |  |  |  |  |  |  |  |  |
| 13641040 |  | Develop/Install/Test FSD Software (MPS) |  | 22d | 2012-11-20 | 2012-12-21 | 13641030 FS-22d | 347d | 0d |  | COMP SCIENT [40 h] | 2,708.4 | MAHONEY K | 1 | 1 | MIKE S |  |  | 12-037 |  |  |  |  |  |  |  |  |  |  |  |  |  |  |  |  |  |  |
| 13641045M |  | FSD Sys Comp (MPS) | milestone | 0d | 2012-12-21 | 2012-12-21 | 13641035, 13641030a, 13641040 | 347d | 247d |  |  |  | MAHONEY K | 1 | 1 | MIKE S |  |  | 12-037 |  |  |  |  |  |  | 6 |  |  |  |  |  |  |  |  |  |  |  |
| 13641095 |  | Install/Test Tagger/Hall D Beam Loss Monitoring Sys (MPS) |  | 42d | 2013-01-14 | 2013-03-14 | 16332010U, 16333030, 16332030, 9-130M FS+67d, 13641090 | 296d | 0d |  | ELEC TECH [120 h]; ELEC ENG [40 h] | 8,377.2 | MAHONEY K | 1 | 1 | MIKE S |  |  | 12-037 |  |  | 09-015 |  |  |  |  |  |  |  |  |  |  |  |  |  |  |  |
| 13641065 |  | Install BLM Hardware (MPS) |  | 20d | 2013-02-15 | 2013-03-15 | 1362020, 9-130M FS+90d, 16332030, 13641055 | 252d | 0d |  | ELEC ENG [40 h]; ELEC TECH [160 h] | 10,198.8 | MAHONEY K | 1 | 1 | MIKE S |  |  | 12-037 |  |  |  |  |  |  |  |  |  |  |  |  |  |  |  |  |  |  |
| 13641100M |  | Beam Loss Ion Chamb Sys Comp (MPS) | milestone | 0d | 2013-03-14 | 2013-03-14 | 13641095 | 296d | 196d |  |  |  | MAHONEY K | 1 | 1 | MIKE S |  |  | 12-037 |  |  |  |  |  |  | 6 |  |  |  |  |  |  |  |  |  |  |  |
| 13641075 |  | Develop/Install/Test BLM Software (MPS) |  | 43d | 2013-03-18 | 2013-05-15 | 13641065 | 252d | 0d |  | COMP SCIENT [80 h] | 5,416.8 | MAHONEY K | 1 | 1 | MIKE S |  |  | 12-037 |  |  |  |  |  |  |  |  |  |  |  |  |  |  |  |  |  |  |
| 13641080M |  | BLM Sys Comp (MPS) | milestone | 0d | 2013-05-15 | 2013-05-15 | 13641060, 13641070, 13641075, 13641014b | 252d | 152d |  |  |  | MAHONEY K | 1 | 1 | MIKE S |  |  | 12-037 |  |  |  |  |  |  | 6 |  |  |  |  |  |  |  |  |  |  |  |
| 13641950 |  | Re-Baseline Actuals Adjustment |  | 1d | 2013-08-30 | 2013-08-30 | 9-130M FS+227d | 20d |  |  | PROCUREMENT>$50K 69 NO ESCALATION | -101,820.84 | MAHONEY K | 1 | 1 | MIKE S |  |  |  |  |  |  |  | 13-014 |  |  | ADJ |  |  |  |  |  |  |  |  |  |  |
| 23641020 |  | Test/QA FSD Hardware (MPS) |  | 9d | 2013-09-03 | 2013-09-13 | 9-130M FS+228d | 119d | 0d | 8/5 M-F w/JLAB Holidays ReBaseline | ELEC TECH [20 h]; ELEC ENG [10 h] | 1,638.9 | MAHONEY K | 1 | 1 | MIKE S |  | 10-031 | 12-037 |  |  |  | 12-053 |  |  |  |  | 23641020 | S | ST | PE | NO | 13-015 | PR |  |  |  |
| 23641030 |  | Install/Test FSD Hardware (MPS) FY13 |  | 20d | 2013-09-03 | 2013-09-30 | 23641020 FS-9d | 119d | 0d | 8/5 M-F w/JLAB Holidays ReBaseline | ELEC ENG [19.23 h]; ELEC TECH [24.28 h] | 2,505.81 | MAHONEY K | 1 | 1 | MIKE S |  | 10-031 | 12-037 |  |  |  |  |  |  |  |  | 23641030 | S | ST | PE | NO | 13-015 | PR |  |  |  |
| 23641055 |  | Test/QA BLM Hardware (MPS) FY13 |  | 20d | 2013-09-03 | 2013-09-30 | 9-130M FS+228d | 134d | 0d | 8/5 M-F w/JLAB Holidays ReBaseline | ELEC ENG [19.2 h]; ELEC TECH [19.2 h] | 2,272.32 | MAHONEY K | 1 | 1 | MIKE S |  |  | 12-037F |  |  |  |  |  |  |  |  | 23641055 | S | ST | PE | NO | 13-015 | PR |  |  |  |
| 23641060 |  | Install BLM Wire & Cable (MPS) FY13 |  | 20d | 2013-09-03 | 2013-09-30 | 9-130M FS+228d | 99d | 0d | 8/5 M-F w/JLAB Holidays ReBaseline | ELEC ENG [8.34 h]; ELEC DES [1.26 h]; ELEC TECH [30.32 h] | 2,053.64 | MAHONEY K | 1 | 1 | MIKE S |  |  | 12-037 |  |  |  |  |  |  |  |  | 23641060 | S | ST | PE | NO | 13-015 | PR |  |  |  |
| 23641065 |  | Install BLM Hardware (MPS) FY13 |  | 20d | 2013-09-03 | 2013-09-30 | 23641055 FS-60d, 23641060 FS-57d, 23641060a FS-57d, 23641055a FS-60d | 99d | 0d | 8/5 M-F w/JLAB Holidays ReBaseline | ELEC ENG [6.95 h]; ELEC TECH [27.79 h] | 1,771.53 | MAHONEY K | 1 | 1 | MIKE S |  |  | 12-037 |  |  |  |  |  |  |  |  | 23641065 | S | ST | PE | NO | 13-015 | PR |  |  |  |
| 23641085 |  | Proc Tagger/Hall D Beam Loss Monitoring Hardware (MPS) |  | 20d | 2013-09-03 | 2013-09-30 | 9-130M FS+228d | 129d | 108d | 8/5 M-F w/JLAB Holidays ReBaseline | PROCUREMENT<$50K 60 | 8,000 | MAHONEY K | 1 | 1 | MIKE S |  |  | 12-037 |  |  |  |  |  |  |  |  | 23641065 | S | ST | PE | NO | 13-015 | PR | y | OB |  |
| 23641087 |  | Install BLM Wire & Cable (MPS) Tagger Hall D FY13 |  | 20d | 2013-09-03 | 2013-09-30 | 9-130M FS+228d | 40d | 0d | 8/5 M-F w/JLAB Holidays ReBaseline | ELEC TECH [84.71 h]; ELEC ENG [22.87 h]; ELEC DES [2.54 h] | 5,655.28 | MAHONEY K | 1 | 1 | MIKE S |  |  | 12-037 |  |  |  |  |  |  |  |  | 23641087 | S | ST | PE | NO | 13-015 | PR |  |  |  |
| 23641090 |  | Test/QA Tagger/Hall D Beam Loss Monitoring Hardware (MPS) FY13 |  | 20d | 2013-09-03 | 2013-09-30 | 23641087a FS-85d, 23641087 FS-85d | 40d | 0d | 8/5 M-F w/JLAB Holidays ReBaseline | ELEC ENG [7.62 h]; ELEC TECH [15.24 h] | 1,248.84 | MAHONEY K | 1 | 1 | MIKE S |  |  | 12-037F |  |  | 09-015 |  |  |  |  |  | 23641090 | S | ST | PE | NO | 13-015 | PR |  |  |  |
| 23641913LOE |  | FY13 Mngmnt & Elect Dsgn Supprt Effort for MPS |  | 20d | 2013-09-03 | 2013-09-30 | 9-130M FS+228d | 142d | 0d | 8/5 M-F w/JLAB Holidays ReBaseline | ELEC DES [5.16 h]; SR STAFF [2.9 h] | 607.2 | MAHONEY K | 1 | 1 | MIKE S |  |  |  |  |  |  |  |  |  |  |  | 23641913LOE | E |  | PE | NO | 13-015 | PR |  |  |  |
| 23641030a |  | Install/Test FSD Hardwarefor RF Installation(MPS) FY13 |  | 11d | 2013-09-16 | 2013-09-30 | 9-130M FS+237d | 133d | 0d | 8/5 M-F w/JLAB Holidays ReBaseline | ELEC TECH [12.94 h]; ELEC ENG [12.94 h] | 1,531.45 | MAHONEY K | 1 | 1 | MIKE S |  | 10-031 | 12-037F |  |  |  |  |  |  |  |  | 23641030a | S | ST | PE | NO | 13-015 | PR |  |  |  |
| 23641040 |  | Develop/Install/Test FSD Software (MPS) FY13 |  | 11d | 2013-09-16 | 2013-09-30 | 9-130M FS+237d | 133d | 0d | 8/5 M-F w/JLAB Holidays ReBaseline | COMP SCIENT [25.88 h] | 1,752.33 | MAHONEY K | 1 | 1 | MIKE S |  |  | 12-037 |  |  |  |  |  |  |  |  | 23641040 | S | ST | PE | NO | 13-015 | PR |  |  |  |
| 23641025 |  | Install FSD Wire & Cable (MPS) FY13 |  | 6d | 2013-09-23 | 2013-09-30 | 9-130M FS+242d | 122d | 0d | 8/5 M-F w/JLAB Holidays ReBaseline | ELEC ENG [4.24 h]; ELEC TECH [41.64 h] | 2,204.98 | MAHONEY K | 1 | 1 | MIKE S |  | 10-031 | 12-037F |  |  |  | 12-053 |  |  |  |  | 23641025 | S | ST | PE | NO | 13-015 | PR |  |  |  |
| 23641025a |  | Install FSD Wire & Cable (MPS) FY14 |  | 34d | 2013-10-01 | 2013-11-15 | 9-130M FS+242d, 23641025 | 122d | 3d | 8/5 M-F w/JLAB Holidays ReBaseline | ELEC ENG [24.02 h]; ELEC TECH [235.96 h] | 12,892.41 | MAHONEY K | 1 | 1 | MIKE S |  | 10-031 | 12-037F |  |  |  | 12-053 |  |  |  |  | 23641025 | S | ST | PE | NO | 13-015 | PR |  |  | 14-001 |
| 23641030aa |  | Install/Test FSD Hardwarefor RF Installation(MPS) FY14 |  | 23d | 2013-10-01 | 2013-10-31 | 23641030a, 9-130M FS+237d | 133d | 14d | 8/5 M-F w/JLAB Holidays ReBaseline | ELEC TECH [27.06 h]; ELEC ENG [27.06 h] | 3,304.57 | MAHONEY K | 1 | 1 | MIKE S |  | 10-031 | 12-037F |  |  |  |  |  |  |  |  | 23641030a | S | ST | PE | NO | 13-015 | PR |  |  | 14-001 |
| 23641030b |  | Install/Test FSD Hardware (MPS) FY14 |  | 37d | 2013-10-01 | 2013-11-20 | 23641020 FS-9d, 23641030 | 119d | 0d | 8/5 M-F w/JLAB Holidays ReBaseline | ELEC ENG [35.57 h]; ELEC TECH [44.92 h] | 4,783.21 | MAHONEY K | 1 | 1 | MIKE S |  | 10-031 | 12-037 |  |  |  |  |  |  |  |  | 23641030 | S | ST | PE | NO | 13-015 | PR |  |  | 14-001 |
| 23641040a |  | Develop/Install/Test FSD Software (MPS) FY14 |  | 23d | 2013-10-01 | 2013-10-31 | 9-130M FS+237d, 23641040 | 133d | 14d | 8/5 M-F w/JLAB Holidays ReBaseline | COMP SCIENT [54.12 h] | 3,781.36 | MAHONEY K | 1 | 1 | MIKE S |  |  | 12-037 |  |  |  |  |  |  |  |  | 23641040 | S | ST | PE | NO | 13-015 | PR |  |  | 14-001 |
| 23641055a |  | Test/QA BLM Hardware (MPS) FY14 |  | 5d | 2013-10-01 | 2013-10-07 | 23641055, 9-130M FS+228d | 134d | 35d | 8/5 M-F w/JLAB Holidays ReBaseline | ELEC ENG [4.8 h]; ELEC TECH [4.8 h] | 586.17 | MAHONEY K | 1 | 1 | MIKE S |  |  | 12-037F |  |  |  |  |  |  |  |  | 23641055 | S | ST | PE | NO | 13-015 | PR |  |  | 14-001 |
| 23641060a |  | Install BLM Wire & Cable (MPS) FY14 |  | 37d | 2013-10-01 | 2013-11-20 | 9-130M FS+228d, 23641060 | 99d | 0d | 8/5 M-F w/JLAB Holidays ReBaseline | ELEC ENG [15.42 h]; ELEC DES [2.34 h]; ELEC TECH [56.08 h] | 3,919.6 | MAHONEY K | 1 | 1 | MIKE S |  |  | 12-037 |  |  |  |  |  |  |  |  | 23641060 | S | ST | PE | NO | 13-015 | PR |  |  | 14-001 |
| 23641065a |  | Install BLM Hardware (MPS) FY14 |  | 37d | 2013-10-01 | 2013-11-20 | 23641060 FS-57d, 23641055 FS-60d, 23641060a FS-57d, 23641065, 23641055a FS-60d | 99d | 0d | 8/5 M-F w/JLAB Holidays ReBaseline | ELEC ENG [12.85 h]; ELEC TECH [51.42 h] | 3,381.76 | MAHONEY K | 1 | 1 | MIKE S |  |  | 12-037 |  |  |  |  |  |  |  |  | 23641065 | S | ST | PE | NO | 13-015 | PR |  |  | 14-001 |
| 23641087a |  | Install BLM Wire & Cable (MPS) Tagger Hall D FY14 |  | 65d | 2013-10-01 | 2014-01-13 | 9-130M FS+228d, 23641087 | 40d | 0d | 8/5 M-F w/JLAB Holidays ReBaseline | ELEC TECH [275.29 h]; ELEC ENG [74.33 h]; ELEC DES [8.26 h] | 18,964.48 | MAHONEY K | 1 | 1 | MIKE S |  |  | 12-037 |  |  |  |  |  |  |  |  | 23641087 | S | ST | PE | NO | 13-015 | PR |  |  | 14-001 |
| 23641090a |  | Test/QA Tagger/Hall D Beam Loss Monitoring Hardware (MPS) FY14 |  | 64d | 2013-10-01 | 2014-01-10 | 23641087a FS-85d, 23641090, 23641087 FS-85d | 40d | 0d | 8/5 M-F w/JLAB Holidays ReBaseline | ELEC ENG [24.38 h]; ELEC TECH [48.76 h] | 4,122.9 | MAHONEY K | 1 | 1 | MIKE S |  |  | 12-037F |  |  | 09-015 |  |  |  |  |  | 23641090 | S | ST | PE | NO | 13-015 | PR |  |  | 14-001 |
| 23641100 |  | Rework FSD Cards |  | 35d | 2013-10-01 | 2013-11-18 | 9-140M | 94d | 73d | 8/5 M-F w/JLAB Holidays ReBaseline | PROCUREMENT<$50K 60 | 4,127.6 | MAHONEY K | 1 | 1 | MIKE S |  |  | 12-037 |  |  |  |  |  |  |  |  | 23641065 | S | ST | PE | NO | 13-015 | PR |  |  | 14-001 |
| 23641914LOE |  | FY14 Mngmnt & Elect Dsgn Supprt Effort for MPS |  | 163d | 2013-10-01 | 2014-06-02 | 23641913LOE | 142d |  | 8/5 M-F w/JLAB Holidays ReBaseline | ELEC DES [38.45 h]; SR STAFF [21.63 h] | 4,670.36 | MAHONEY K | 1 | 1 | MIKE S |  |  |  |  |  |  |  |  |  |  |  | 23641914LOE | E |  | PE | NO | 13-015 | PR |  |  | 14-001 |
| 23641075 |  | Develop/Install/Test BLM Software (MPS) |  | 24d | 2013-11-15 | 2013-12-20 | 23641065a FS-4d, 23641065 FS-4d | 99d | 0d | 8/5 M-F w/JLAB Holidays ReBaseline | COMP SCIENT [80 h] | 5,589.6 | MAHONEY K | 1 | 1 | MIKE S |  |  | 12-037 |  |  |  |  |  |  |  |  | 23641075 | S | ST | PE | NO | 13-015 | PR |  |  | 14-001 |
| 23641045M |  | FSD Sys Comp (MPS) | milestone | 0d | 2013-11-20 | 2013-11-20 | 23641040, 23641030b, 23641030aa, 23641025, 23641040a, 23641030a, 23641030, 23641025a | 119d | 20d | 8/5 M-F w/JLAB Holidays ReBaseline |  |  | MAHONEY K | 1 | 1 | MIKE S |  |  | 12-037 |  |  |  |  |  |  | 6 |  | 23641045M | M |  |  | NO | 13-015 | PR |  |  |  |
| 23641080M |  | BLM Sys Comp (MPS) | milestone | 0d | 2013-12-20 | 2013-12-20 | 23641060, 23641075, 23641060a | 99d | 0d | 8/5 M-F w/JLAB Holidays ReBaseline |  |  | MAHONEY K | 1 | 1 | MIKE S |  |  | 12-037 |  |  |  |  |  |  | 6 |  | 23641080M | M |  |  | NO | 13-015 | PR |  |  |  |
| 23641095 |  | Install/Test Tagger/Hall D Beam Loss Monitoring Sys (MPS) |  | 29d | 2014-01-07 | 2014-02-17 | 23641090 FS-4d, 23641090a FS-4d | 40d | 0d | 8/5 M-F w/JLAB Holidays ReBaseline | ELEC TECH [60 h]; ELEC ENG [20 h] | 4,321.95 | MAHONEY K | 1 | 1 | MIKE S |  |  | 12-037 |  |  | 09-015 |  |  |  |  |  | 23641095 | S | ST | PE | NO | 13-015 | PR |  |  | 14-001 |
| 23641100M |  | Beam Loss Ion Chamb Sys Comp (MPS) | milestone | 0d | 2014-02-17 | 2014-02-17 | 23641095 | 40d | 19d | 8/5 M-F w/JLAB Holidays ReBaseline |  |  | MAHONEY K | 1 | 1 | MIKE S |  |  | 12-037 |  |  |  |  |  |  | 6 |  | 23641100M | M |  |  | NO | 13-015 | PR |  |  |  |

Notes:
- 13641025a: Entry Criteria: Ext Pred: BOD Tagger Bldg, BOD / Hall D
- 13641025ab: Entry Criteria: Ext Pred: BOD Tagger Bldg, BOD / Hall D
- 13641030a: Entry Criteria: Ext Pred: BOD Tagger Bldg, BOD / Hall D
- 13641025: Entry Criteria: Ext Pred: BOD Tagger Bldg, BOD / Hall D
- 13641025b: Entry Criteria: Ext Pred: BOD Tagger Bldg, BOD / Hall D
- 13641030: Entry Criteria: Ext Pred: BOD Tagger Bldg, BOD / Hall D
- 13641060: Entry Criteria: Ext Pred: BOD Tagger Bldg, BOD / Tunnel Ext, New CMs installed
- 13641095: Entry Criteria: Ext Pred: BOD Tagger Bldg, BOD / Tunnel Ext
- 23641020: Steps: Characterization; Integrated Test / BOE NOTES: Based on implementation of similar cards for the South Linac RF C-100 systems.
- 23641030: Entry Criteria: Ext Pred: BOD Tagger Bldg, BOD / Hall D / Steps: Install/Test FSD Master; Install/Test Tagger FSD HW; Install/Test Hall D FSD HW
- 23641055: Steps: Test with Light Pulse
- 23641060: Entry Criteria: Ext Pred: BOD Tagger Bldg, BOD / Tunnel Ext, New CMs installed / Steps: Install NL-Hall D Xport BLM Cables; Install FSD Infrastructure; Terminate/QA Cables; As-Built Documentation
- 23641065: Steps: Install Ion Chamber Electronics; Install BLM Cards; Install BLM HVPS
- 23641085: Steps: Install Ion Chamber Electronics; Install BLM Cards; Install BLM HVPS
- 23641087: Entry Criteria: Ext Pred: BOD Tagger Bldg, BOD / Tunnel Ext, New CMs installed / Steps: Install Tagger BLM Cables; Install Hall D BLM Cables; Terminate/QA Cables; As-Built Documentation / BOE NOTES: Based on similar installs in endstations and CEBAF accelerator.
- 23641090: Steps: Test Ion Chamber Electronics; Characterize Ion Chambers; Test IC Subsystem
- 23641913LOE: BOE NOTES: Demands for management reports such as this were not in estimate.
- 23641030a: Entry Criteria: Ext Pred: BOD Tagger Bldg, BOD / Hall D / Steps: Install/Test 1L23 FSD; Connect RF Inputs; Connect to FSD Tree; Test
- 23641040: Steps: Test EPICS SW; Finalize Screens
- 23641025: Entry Criteria: Ext Pred: BOD Tagger Bldg, BOD / Hall D / Steps: Install NL Extension; Install Tagger FSD Fiber and Cable; Install Hall D FSD Fiber and Cable; Install FSD Tree Interconnect / BOE NOTES: Copper cable prices unstable. Still trending up.
- 23641025a: Entry Criteria: Ext Pred: BOD Tagger Bldg, BOD / Hall D / Steps: Install NL Extension; Install Tagger FSD Fiber and Cable; Install Hall D FSD Fiber and Cable; Install FSD Tree Interconnect / BOE NOTES: Copper cable prices unstable. Still trending up.
- 23641030aa: Entry Criteria: Ext Pred: BOD Tagger Bldg, BOD / Hall D / Steps: Install/Test 1L23 FSD; Connect RF Inputs; Connect to FSD Tree; Test
- 23641030b: Entry Criteria: Ext Pred: BOD Tagger Bldg, BOD / Hall D / Steps: Install/Test FSD Master; Install/Test Tagger FSD HW; Install/Test Hall D FSD HW
- 23641040a: Steps: Test EPICS SW; Finalize Screens
- 23641055a: Steps: Test with Light Pulse
- 23641060a: Entry Criteria: Ext Pred: BOD Tagger Bldg, BOD / Tunnel Ext, New CMs installed / Steps: Install NL-Hall D Xport BLM Cables; Install FSD Infrastructure; Terminate/QA Cables; As-Built Documentation
- 23641065a: Steps: Install Ion Chamber Electronics; Install BLM Cards; Install BLM HVPS
- 23641087a: Entry Criteria: Ext Pred: BOD Tagger Bldg, BOD / Tunnel Ext, New CMs installed / Steps: Install Tagger BLM Cables; Install Hall D BLM Cables; Terminate/QA Cables; As-Built Documentation / BOE NOTES: Based on similar installs in endstations and CEBAF accelerator.
- 23641090a: Steps: Test Ion Chamber Electronics; Characterize Ion Chambers; Test IC Subsystem
- 23641100: Steps: Install Ion Chamber Electronics; Install BLM Cards; Install BLM HVPS
- 23641914LOE: BOE NOTES: Based on experience supporting 12GeV project. Addition is due to extending effort in to Fy14.
- 23641075: Steps: Test EPICS SW; Finalize Screens
- 23641095: Entry Criteria: Ext Pred: BOD Tagger Bldg, BOD / Tunnel Ext / Steps: Finalize Documentation; Install BLM Heads; Install Ion Chambers; Install Ion Chamber HV Box / BOE NOTES: First installation of new VME based BLM card.

| ID | WBS | Activity | Type | Duration | Start | Finish | Predecessors | Total float | Free float | Calendar | Resources | Cost | RESP - Responsibility | STRT%COMP for CM EVM | FNSH%COMP for CM EVM | CAM RESPONSIBLE | CR 08-058 | CR 10-028 | CR 12-037 | CR 13-014 | CR 13-003 | Milestone Level | ReBaseline Actuals Adjustment | Original Activity ID Rebaseline | EVMS Reporting Codes | BOE Labor | BOE Adder | CR 13-015 | Post Rebaseline | Activities with Steps | BOE Procurement | CR 14-001 | BOE Expenses | CR 08-016 | CR 09-012 | CR 10-031 | CR 12-001 | CR 12-018 | CR 10-064 | CR 10-065 | CR 10-066 | CR 12-053 | CR 10-070 | CR 11-044 | CR 10-059 | CR 12-045 |
| --- | --- | --- | --- | --- | --- | --- | --- | --- | --- | --- | --- | --- | --- | --- | --- | --- | --- | --- | --- | --- | --- | --- | --- | --- | --- | --- | --- | --- | --- | --- | --- | --- | --- | --- | --- | --- | --- | --- | --- | --- | --- | --- | --- | --- | --- | --- |
|  | 2 | **1.3.6.4.2 BELS** |  |  | 2009-01-02 | 2014-06-02 |  |  |  |  |  |  |  |  |  |  |  |  |  |  |  |  |  |  |  |  |  |  |  |  |  |  |  |  |  |  |  |  |  |  |  |  |  |  |  |  |
| 13642909LOE |  | FY09 Mngmnt & Elect Dsgn Supprt Effort for BELS |  | 189d | 2009-01-02 | 2009-09-30 | 13642909LOEX | 20d | 0d |  | SR STAFF [3.05 h]; ELEC DES [3.05 h] | 453.9 | MAHONEY K | 1 | 1 | MIKE S | 08-058 |  |  |  |  |  |  |  |  |  |  |  |  |  |  |  |  |  |  |  |  |  |  |  |  |  |  |  |  |  |
| 13642910LOE |  | FY10 Mngmnt & Elect Dsgn Supprt Effort for BELS |  | 248d | 2009-10-01 | 2010-09-30 | 13642909LOE | 20d | 0d |  | ELEC DES [4 h]; SR STAFF [4 h] | 614.24 | MAHONEY K | 1 | 1 | MIKE S |  |  |  |  |  |  |  |  |  |  |  |  |  |  |  |  |  |  |  |  |  |  |  |  |  |  |  |  |  |  |
| 13642911LOE |  | FY11 Mngmnt & Elect Dsgn Supprt Effort for BELS |  | 248d | 2010-10-01 | 2011-09-30 | 13642910LOE | 20d | 0d |  | SR STAFF [36 h]; ELEC DES [36 h] | 5,704.56 | MAHONEY K | 1 | 1 | MIKE S |  |  |  |  |  |  |  |  |  |  |  |  |  |  |  |  |  |  |  |  |  |  |  |  |  |  |  |  |  |  |
| 13642912LOE |  | FY12 Mngmnt & Elect Dsgn Supprt Effort for BELS |  | 247d | 2011-10-03 | 2012-09-28 | 13642911LOE | 20d | 0d |  | ELEC DES [36 h]; SR STAFF [36 h] | 5,886.36 | MAHONEY K | 1 | 1 | MIKE S |  |  |  |  |  |  |  |  |  |  |  |  |  |  |  |  |  |  |  |  |  |  |  |  |  |  |  |  |  |  |
| 13642014 |  | Proc BELS Hardware |  | 75d | 2012-01-05 | 2012-04-20 | 9-120M FS+60d, 121642070M, 121642170 | 295d | 223d |  | PROCUREMENT<$50K 60; ELEC ENG [40 h] | 28,656.13 | MAHONEY K | 1 | 1 | MIKE S |  | 10-028 | 12-037F |  |  |  |  |  |  |  |  |  |  |  |  |  |  |  |  |  |  |  |  |  |  |  |  |  |  |  |
| 13642913LOE |  | FY13 Mngmnt & Elect Dsgn Supprt Effort for BELS |  | 228d | 2012-10-01 | 2013-08-30 | 13642912LOE | 20d |  |  | ELEC DES [33.09 h]; SR STAFF [33.09 h] | 5,583.79 | MAHONEY K | 1 | 1 | MIKE S |  |  |  | 13-014 |  |  |  |  |  |  |  |  |  |  |  |  |  |  |  |  |  |  |  |  |  |  |  |  |  |  |
| 13642019 |  | Proc Remaining BELS Hardware |  | 40d | 2013-01-17 | 2013-03-15 | 9-130M FS+70d | 73d | 1d |  | PROCUREMENT<$50K 60 | 3,000 | MAHONEY K | 1 | 1 | MIKE S |  | 10-028 | 12-037F |  | 13-003 |  |  |  |  |  |  |  |  |  |  |  |  |  |  |  |  |  |  |  |  |  |  |  |  |  |
| 13642015 |  | Test/QA BELS Compnts |  | 22d | 2013-03-19 | 2013-04-17 | 13642014, 13642019, 9-130M FS+111d | 72d | 0d |  | ELEC ENG [40 h]; ELEC TECH [160 h] | 10,198.8 | MAHONEY K | 1 | 1 | MIKE S |  | 10-028 | 12-037 |  |  |  |  |  |  |  |  |  |  |  |  |  |  |  |  |  |  |  |  |  |  |  |  |  |  |  |
| 13642020 |  | Install BELS Hardware |  | 43d | 2013-04-18 | 2013-06-18 | 13642015, 16332030, 9-130M FS+45d | 72d | 0d |  | PLABOR; ELEC ENG [40 h]; ELEC TECH [240 h] | 18,841.56 | MAHONEY K | 1 | 1 | MIKE S |  |  | 12-037 |  |  |  |  |  |  |  |  |  |  |  |  |  |  |  |  |  |  |  |  |  |  |  |  |  |  |  |
| 13642005 |  | Develop/Install/Test BELS Software |  | 30d | 2013-05-21 | 2013-07-02 | 13642015, 13642020 FS-20d | 72d | 0d |  | COMP SCIENT [80 h]; ELEC ENG [80 h] | 11,241.6 | MAHONEY K | 1 | 1 | MIKE S |  |  | 12-037 |  |  |  |  |  |  |  |  |  |  |  |  |  |  |  |  |  |  |  |  |  |  |  |  |  |  |  |
| 13642030M |  | BELS Sys Comp | milestone | 0d | 2013-07-02 | 2013-07-02 | 13642020, 13642005 | 72d |  |  |  |  | MAHONEY K | 1 | 1 | MIKE S |  |  | 12-037 |  |  | 6 |  |  |  |  |  |  |  |  |  |  |  |  |  |  |  |  |  |  |  |  |  |  |  |  |
| 13642950 |  | Re-Baseline Actuals Adjustment |  | 1d | 2013-08-30 | 2013-08-30 | 9-130M FS+227d | 20d |  |  | PROCUREMENT>$50K 69 NO ESCALATION | -79,687.15 | MAHONEY K | 1 | 1 | MIKE S |  |  |  | 13-014 |  |  | ADJ |  |  |  |  |  |  |  |  |  |  |  |  |  |  |  |  |  |  |  |  |  |  |  |
| 23642913LOE |  | FY13 Mngmnt & Elect Dsgn Supprt Effort for BELS |  | 20d | 2013-09-03 | 2013-09-30 | 9-130M FS+228d | 142d | 0d | 8/5 M-F w/JLAB Holidays ReBaseline | ELEC DES [2.9 h]; SR STAFF [2.9 h] | 489.29 | MAHONEY K | 1 | 1 | MIKE S |  |  |  |  |  |  |  | 23642913LOE | E | PE | NO | 13-015 | PR |  |  |  |  |  |  |  |  |  |  |  |  |  |  |  |  |  |
| 23642014 |  | Proc BELS Hardware |  | 31d | 2013-10-01 | 2013-11-12 | 9-140M | 21d | 0d | 8/5 M-F w/JLAB Holidays ReBaseline | PROCUREMENT<$50K 60; ELEC ENG [16 h] | 11,865.21 | MAHONEY K | 1 | 1 | MIKE S |  | 10-028 | 12-037F |  |  |  |  | 23642014 | S | PE | NO | 13-015 | PR | ST | CP | 14-001 |  |  |  |  |  |  |  |  |  |  |  |  |  |  |
| 23642019 |  | Proc Remaining BELS Hardware |  | 50d | 2013-10-01 | 2013-12-11 | 9-140M | 21d | 0d | 8/5 M-F w/JLAB Holidays ReBaseline | PROCUREMENT<$50K 60 | 3,095.7 | MAHONEY K | 1 | 1 | MIKE S |  | 10-028 | 12-037F |  | 13-003 |  |  | 23642019 | S | PE | NO | 13-015 | PR | ST | CP | 14-001 |  |  |  |  |  |  |  |  |  |  |  |  |  |  |
| 23642914LOE |  | FY14 Mngmnt & Elect Dsgn Supprt Effort for BELS |  | 163d | 2013-10-01 | 2014-06-02 | 23642913LOE | 142d |  | 8/5 M-F w/JLAB Holidays ReBaseline | ELEC DES [21.63 h]; SR STAFF [21.63 h] | 3,765.78 | MAHONEY K | 1 | 1 | MIKE S |  |  |  |  |  |  |  | 23642914LOE | E | PE | NO | 13-015 | PR |  |  | 14-001 |  |  |  |  |  |  |  |  |  |  |  |  |  |  |
| 23642005 |  | Develop/Install/Test BELS Software |  | 50d | 2013-10-14 | 2014-01-03 | 23642020 FS-120d, 23642015 FS-53d | 70d | 49d | 8/5 M-F w/JLAB Holidays ReBaseline | COMP SCIENT [72 h]; ELEC ENG [72 h] | 10,440 | MAHONEY K | 1 | 1 | MIKE S |  |  | 12-037 |  |  |  |  | 23642005 | S | PE | NO | 13-015 | PR | ST |  | 14-001 |  |  |  |  |  |  |  |  |  |  |  |  |  |  |
| 23642015 |  | Test/QA BELS Compnts |  | 42d | 2013-10-29 | 2014-01-08 | 23642014 FS-11d, 23642019 FS-30d | 21d | 0d | 8/5 M-F w/JLAB Holidays ReBaseline | ELEC ENG [40 h]; ELEC TECH [160 h] | 10,523.6 | MAHONEY K | 1 | 1 | MIKE S |  | 10-028 | 12-037 |  |  |  |  | 23642015 | S | PE | NO | 13-015 | PR | ST |  | 14-001 |  |  |  |  |  |  |  |  |  |  |  |  |  |  |
| 23642020 |  | Install BELS Hardware |  | 22d | 2014-02-13 | 2014-03-14 | 23642015 FS+24d, 9-130M FS+228d | 21d | 0d | 8/5 M-F w/JLAB Holidays ReBaseline | PLABOR; ELEC ENG [56 h]; ELEC TECH [216 h] | 19,516.62 | MAHONEY K | 1 | 1 | MIKE S |  |  | 12-037 |  |  |  |  | 23642020 | S | PE | NO | 13-015 | PR | ST |  | 14-001 | PE |  |  |  |  |  |  |  |  |  |  |  |  |  |
| 23642030M |  | BELS Sys Comp | milestone | 0d | 2014-03-14 | 2014-03-14 | 23642020, 23642005 | 21d | 0d | 8/5 M-F w/JLAB Holidays ReBaseline |  |  | MAHONEY K | 1 | 1 | MIKE S |  |  | 12-037 |  |  | 6 |  | 23642030M | M |  | NO | 13-015 | PR |  |  |  |  |  |  |  |  |  |  |  |  |  |  |  |  |  |
|  | 3 | **1.3.6.4.3 PSS** |  |  | 2009-01-02 | 2014-06-02 |  |  |  |  |  |  |  |  |  |  |  |  |  |  |  |  |  |  |  |  |  |  |  |  |  |  |  |  |  |  |  |  |  |  |  |  |  |  |  |  |
| 13643909LOE |  | FY09 Mngmnt & Supprt Effort for PSS |  | 189d | 2009-01-02 | 2009-09-30 | 13643909LOEX | 20d | 0d |  | ELEC DES [18.29 h]; ELEC ENG [9.15 h]; OFFICE [18.29 h]; SR STAFF [6.1 h] | 2,531.16 | MAHONEY K | 1 | 1 | MIKE S | 08-058 |  |  |  |  |  |  |  |  |  |  |  |  |  |  |  |  |  |  |  |  |  |  |  |  |  |  |  |  |  |
| 13643910LOE |  | FY10 Mngmnt & Supprt Effort for PSS |  | 248d | 2009-10-01 | 2010-09-30 | 13643909LOE | 20d | 0d |  | OFFICE [24 h]; ELEC DES [24 h]; ELEC ENG [12 h]; SR STAFF [8 h] | 3,426.2 | MAHONEY K | 1 | 1 | MIKE S |  |  |  |  |  |  |  |  |  |  |  |  |  |  |  |  |  |  |  |  |  |  |  |  |  |  |  |  |  |  |
| 13643030 |  | Proc Custom Compnts (Run/Safe, Interface Chassis) (PSS) Labor FY11(FY12 @ 13643030b) |  | 248d | 2010-10-01 | 2011-09-30 | 9-110M, 121643140 | 173d | 0d |  | PLABOR; ELEC ENG [7.31 h]; ELEC TECH [14.62 h] | 1,385.75 | MAHONEY K | 1 | 1 | MIKE S |  |  |  |  |  |  |  |  |  |  |  |  |  |  |  |  |  | 08-016 | 09-012 | 10-031 | 12-001 | 12-018F |  |  |  |  |  |  |  |  |
| 13643030a |  | Proc Custom Compnts (Run/Safe, Interface Chassis) for RF Installation (PSS) |  | 72d | 2010-10-01 | 2011-01-21 | 9-110M | 173d | 0d |  | ELEC TECH [60 h]; PLABOR; ELEC ENG [20 h]; PROCUREMENT<$50K 60 | 30,391.72 | MAHONEY K | 1 | 1 | MIKE S |  |  |  |  |  |  |  |  |  |  |  |  |  |  |  |  |  |  |  | 10-031 |  | 12-018F |  |  |  |  |  |  |  |  |
| 13643030c |  | Proc Custom Compnts (Run/Safe, Interface Chassis) (PSS) Procurement |  | 490d | 2010-10-01 | 2012-09-21 | 121643140, 9-110M | 173d | 0d |  | PROCUREMENT<$50K 60 NO ESCALATION FY12 | 8,400.65 | MAHONEY K | 1 | 1 | MIKE S |  |  |  |  |  |  |  |  |  |  |  |  |  |  |  |  |  | 08-016 | 09-012 | 10-031 | 12-001 | 12-018F |  |  |  |  |  |  |  |  |
| 13643160 |  | Create & Simulate PSS Logic Programs |  | 100d | 2010-10-01 | 2011-03-03 | 9-110M | 673d | 219d |  | ELEC ENG [320 h] | 21,881.6 | MAHONEY K | 1 | 1 | MIKE S |  |  | 12-037F |  |  |  |  |  |  |  |  |  |  |  |  |  |  |  |  |  |  |  |  |  |  |  |  |  |  |  |
| 13643911LOE |  | FY11 Mngmnt & Supprt Effort for PSS |  | 248d | 2010-10-01 | 2011-09-30 | 13643910LOE | 20d | 0d |  | ELEC ENG [196 h]; ELEC DES [396 h]; OFFICE [24 h]; SR STAFF [88 h] | 43,087.64 | MAHONEY K | 1 | 1 | MIKE S |  |  |  |  |  |  |  |  |  |  |  |  |  |  |  |  |  |  |  |  |  |  |  |  |  |  |  |  |  |  |
| 13643020a |  | Proc PLC Systems for RF Installation (PSS) |  | 40d | 2010-11-01 | 2011-01-05 | 9-110M FS+21d | 742d | 0d |  | ELEC ENG [40 h]; PROCUREMENT<$50K 60 | 40,502.74 | MAHONEY K | 1 | 1 | MIKE S |  |  | 12-037F |  |  |  |  |  |  |  |  |  |  |  |  |  |  |  |  | 10-031 |  |  | 10-064 |  |  |  |  |  |  |  |
| 13643035 |  | Test/QA Custom Compnts (PSS) FY11 (FY12 @ 13643035b) |  | 218d | 2010-11-12 | 2011-09-30 | 13643030c FS-460d, 13643030b FS-460d | 173d | 0d |  | ELEC TECH [106.78 h] | 4,566.98 | MAHONEY K | 1 | 1 | MIKE S |  |  |  |  |  |  |  |  |  |  |  |  |  |  |  |  |  |  |  | 10-031 | 12-001 | 12-018F |  |  |  |  |  |  |  |  |
| 13643040 |  | Proc Local Cable, Conduit, Infrastructure (PSS) Labor FY11 (FY12 @ 13643040b) |  | 203d | 2010-12-07 | 2011-09-30 | 121643140, 9-110M FS+45d | 35d | 0d |  | ELEC ENG [99.43 h] | 6,799.02 | MAHONEY K | 1 | 1 | MIKE S |  |  |  |  |  |  |  |  |  |  |  |  |  |  |  |  |  | 08-016 | 09-012 | 10-031 | 12-001 |  |  |  |  |  |  |  |  |  |
| 13643040a |  | Proc Local Cable, Conduit, Infrastructure for RF Installation (PSS) |  | 76d | 2010-12-07 | 2011-04-01 | 9-110M FS+45d | 83d | 0d |  | ELEC ENG [40 h]; PROCUREMENT<$50K 60 | 7,094.98 | MAHONEY K | 1 | 1 | MIKE S |  |  |  |  |  |  |  |  |  |  |  |  |  |  |  |  |  |  |  | 10-031 |  |  | 10-064 | 10-065 | 10-066 |  |  |  |  |  |
| 13643040c |  | Proc Local Cable, Conduit, Infrastructure (PSS) Labor Procurement |  | 245d | 2010-12-07 | 2011-12-01 | 9-110M FS+45d, 121643140 | 35d | 29d |  | PROCUREMENT<$50K 60 NO ESCALATION FY12 | 30,743.7 | MAHONEY K | 1 | 1 | MIKE S |  |  |  |  |  |  |  |  |  |  |  |  |  |  |  |  |  | 08-016 | 09-012 | 10-031 | 12-001 |  |  |  |  |  |  |  |  |  |
| 13643050 |  | Proc COTS Compnts (Access Control, Video,etc) (PSS) Labor FY11 |  | 188d | 2011-01-05 | 2011-09-30 | 9-110M FS+60d, 121643140 | 328d | 0d |  | ELEC TECH [184.16 h]; ELEC ENG [245.55 h] | 24,667.23 | MAHONEY K | 1 | 1 | MIKE S |  |  |  |  |  |  |  |  |  |  |  |  |  |  |  |  |  | 08-016 | 09-012 |  | 12-001 | 12-018F |  |  |  |  |  |  |  |  |
| 13643050b |  | Proc COTS Compnts (Access Control, Video,etc) (PSS) Procurement |  | 245d | 2011-01-05 | 2011-12-29 | 9-110M FS+60d, 121643140 | 328d | 0d |  | PROCUREMENT<$50K 60 NO ESCALATION FY12 | 101,795.84 | MAHONEY K | 1 | 1 | MIKE S |  |  |  |  |  |  |  |  |  |  |  |  |  |  |  |  |  | 08-016 | 09-012 |  | 12-001 | 12-018F |  |  |  |  |  |  |  |  |
| 13643025a |  | Test/QA PLC Systems for RF Installation (PSS) |  | 30d | 2011-01-06 | 2011-02-17 | 13643020a | 742d | 307d |  | ELEC TECH [16 h]; ELEC ENG [24 h] | 2,325.44 | MAHONEY K | 1 | 1 | MIKE S |  |  | 12-037F |  |  |  |  |  |  |  |  |  |  |  |  |  |  |  |  | 10-031 |  |  | 10-064 |  |  |  |  |  |  |  |
| 13643035a |  | Test/QA Custom Compnts for RF Installation (PSS) FY11 |  | 176d | 2011-01-24 | 2011-09-30 | 13643030a | 173d | 0d |  | ELEC TECH [31.43 h] | 1,344.26 | MAHONEY K | 1 | 1 | MIKE S |  |  |  |  |  |  |  |  |  |  |  |  |  |  |  |  |  |  |  | 10-031 | 12-001 | 12-018F |  |  |  |  |  |  |  |  |
| 13643045a |  | Install Linac Cable Conduit, Infrastructure for RF Installation (PSS) |  | 44d | 2011-05-02 | 2011-07-01 | 13643040a FS+20d | 83d | 0d |  | ELEC TECH [180 h]; ELEC DES [60 h] | 10,635.6 | MAHONEY K | 1 | 1 | MIKE S |  |  |  |  |  |  |  |  |  |  |  |  |  |  |  |  |  |  |  | 10-031 |  |  | 10-064 | 10-065 | 10-066 |  |  |  |  |  |
| 13643165a |  | Install & Test PSS Logic Programs for Linac RF Upgrade |  | 6d | 2011-07-25 | 2011-08-01 | 13643045a FS+14d | 83d | 0d |  | ELEC TECH [20 h]; ELEC ENG [20 h] | 2,223 | MAHONEY K | 1 | 1 | MIKE S |  |  |  |  |  |  |  |  |  |  |  |  |  |  |  |  |  |  |  | 10-031 |  |  | 10-064 | 10-065 | 10-066 |  |  |  |  |  |
| 13643172M |  | Linac RF PSS Systems Comp | milestone | 0d | 2011-08-11 | 2011-08-11 | 13643165a FS+8d | 83d | 0d |  |  |  | MAHONEY K | 1 | 1 | MIKE S |  |  |  |  |  | 6 |  |  |  |  |  |  |  |  |  |  |  |  |  | 10-031 |  |  | 10-064 | 10-065 | 10-066 |  |  |  |  |  |
| 13643030b |  | Proc Custom Compnts (Run/Safe, Interface Chassis) (PSS) Labor FY12 (FY11 @ 13643030) |  | 242d | 2011-10-03 | 2012-09-21 | 13643030 | 173d | 0d |  | PLABOR; ELEC ENG [7.13 h]; ELEC TECH [14.26 h] | 1,394.78 | MAHONEY K | 1 | 1 | MIKE S |  |  |  |  |  |  |  |  |  |  |  |  |  |  |  |  |  | 08-016 | 09-012 | 10-031 | 12-001 | 12-018F |  |  |  |  |  |  |  |  |
| 13643035ab |  | Test/QA Custom Compnts for RF Installation (PSS) FY12 |  | 247d | 2011-10-03 | 2012-09-28 | 13643035a | 173d | 0d |  | ELEC TECH [44.11 h] | 1,946.57 | MAHONEY K | 1 | 1 | MIKE S |  |  |  |  |  |  |  |  |  |  |  |  |  |  |  |  |  |  |  | 10-031 | 12-001 | 12-018F |  |  |  | 12-053 |  |  |  |  |
| 13643035b |  | Test/QA Custom Compnts (PSS) FY12 (FY11 @ 13643035) |  | 247d | 2011-10-03 | 2012-09-28 | 13643035 | 173d | 0d |  | ELEC TECH [120.98 h] | 5,338.85 | MAHONEY K | 1 | 1 | MIKE S |  |  |  |  |  |  |  |  |  |  |  |  |  |  |  |  |  |  |  | 10-031 | 12-001 | 12-018F |  |  |  | 12-053 |  |  |  |  |
| 13643040b |  | Proc Local Cable, Conduit, Infrastructure (PSS) Labor FY12 (FY11 @ 13643040) |  | 42d | 2011-10-03 | 2011-12-01 | 13643040 | 35d | 29d |  | ELEC ENG [20.57 h] | 1,451.42 | MAHONEY K | 1 | 1 | MIKE S |  |  |  |  |  |  |  |  |  |  |  |  |  |  |  |  |  | 08-016 | 09-012 | 10-031 | 12-001 |  |  |  |  |  |  |  |  |  |
| 13643050a |  | Proc COTS Compnts (Access Control, Video,etc) (PSS) Labor FY12 |  | 57d | 2011-10-03 | 2011-12-29 | 13643050 | 328d | 0d |  | ELEC TECH [55.84 h]; ELEC ENG [74.45 h] | 7,717.41 | MAHONEY K | 1 | 1 | MIKE S |  |  |  |  |  |  |  |  |  |  |  |  |  |  |  |  |  | 08-016 | 09-012 |  | 12-001 | 12-018F |  |  |  |  |  |  |  |  |
| 13643125 |  | Proc ODH Monitoring Sys (PSS) |  | 30d | 2011-10-03 | 2011-11-11 | 9-120M, 121643140 | 415d | 0d |  | ELEC ENG [40 h] | 2,822.4 | MAHONEY K | 1 | 1 | MIKE S |  |  | 12-037F |  |  |  |  |  |  |  |  |  |  |  |  |  |  |  |  |  |  |  |  |  |  |  |  |  |  |  |
| 13643912LOE |  | FY12 Mngmnt & Supprt Effort for PSS |  | 247d | 2011-10-03 | 2012-09-28 | 13643911LOE | 20d | 0d |  | OFFICE [24 h]; SR STAFF [88 h]; ELEC ENG [196 h]; ELEC DES [396 h] | 44,460.92 | MAHONEY K | 1 | 1 | MIKE S |  |  |  |  |  |  |  |  |  |  |  |  |  |  |  |  |  |  |  |  |  |  |  |  |  |  |  |  |  |  |
| 13643020 |  | Proc PLC Systems (PSS) |  | 40d | 2011-11-01 | 2012-01-05 | 9-120M FS+21d, 121643140 | 494d | 0d |  | PROCUREMENT<$50K 60; ELEC ENG [80 h] | 37,071.73 | MAHONEY K | 1 | 1 | MIKE S |  |  | 12-037F |  |  |  |  |  |  |  |  |  |  |  |  |  |  |  |  | 10-031 |  |  | 10-064 |  |  |  |  |  |  |  |
| 13643130 |  | Test/QA ODH Monitoring Sys (PSS) |  | 30d | 2011-11-14 | 2012-01-04 | 13643125 | 415d | 0d |  | ELEC TECH [80 h]; ELEC ENG [40 h] | 6,352.8 | MAHONEY K | 1 | 1 | MIKE S |  |  | 12-037F |  |  |  |  |  |  |  |  |  |  |  |  |  |  |  |  |  |  |  |  |  |  |  |  |  |  |  |
| 13643075 |  | Install RF, Mag Interfaces (PSS) |  | 30d | 2011-12-01 | 2012-01-20 | 16111025, 16332030, 13224020 | 554d | 493d |  | ELEC TECH [120 h]; ELEC ENG [120 h] | 13,762.8 | MAHONEY K | 1 | 1 | MIKE S |  |  | 12-037F |  |  |  |  |  |  |  |  |  |  |  |  |  |  |  |  |  |  |  |  |  | 10-066 |  | 10-070 | 11-044 |  |  |
| 13643085 |  | Fab & Install Tagger Bldg. Racks (PSS) |  | 30d | 2011-12-01 | 2012-01-20 | 16332030 | 6d | 0d |  | ELEC ENG [40 h]; ELEC TECH [80 h]; PLABOR | 15,739.76 | MAHONEY K | 1 | 1 | MIKE S |  |  |  |  |  |  |  |  |  |  |  |  |  |  |  |  |  |  |  |  |  |  |  |  |  |  |  | 11-044 | 10-059 |  |
| 13643090 |  | Fab & Install H-D Racks PSS |  | 30d | 2011-12-01 | 2012-01-20 | 16332030 | 6d | 0d |  | PLABOR; ELEC ENG [40 h]; ELEC TECH [80 h] | 15,725.71 | MAHONEY K | 1 | 1 | MIKE S |  |  |  |  |  |  |  |  |  |  |  |  |  |  |  |  |  |  |  |  |  |  |  |  |  |  |  | 11-044 | 10-059 |  |
| 13643055 |  | Test/QA COTS Compnts (PSS) |  | 60d | 2011-12-30 | 2012-03-27 | 13643050a, 13643050b | 328d | 183d |  | ELEC ENG [40 h]; ELEC TECH [400 h] | 20,474.4 | MAHONEY K | 1 | 1 | MIKE S |  |  |  |  |  |  |  |  |  |  |  |  |  |  |  |  |  |  |  |  |  | 12-018F |  |  |  |  |  |  |  |  |
| 13643014 |  | Let Endstation PSS Cable Plant Contract |  | 40d | 2012-01-05 | 2012-03-02 | 9-120M FS+60d, 16332030 FS-60d | 312d | 0d |  | ELEC ENG [144 h]; PROCUREMENT<$50K 60 | 31,290.96 | MAHONEY K | 1 | 1 | MIKE S |  |  | 12-037F |  |  |  |  |  |  |  |  |  |  |  |  |  |  |  |  |  |  | 12-018F |  |  |  |  |  |  |  |  |
| 13643060 |  | Proc Beam Transport Monitor Compnts (PSS) |  | 40d | 2012-01-05 | 2012-03-02 | 9-120M FS+60d, 121643140 | 471d | 0d |  | ELEC ENG [80 h]; ELEC DES [40 h]; PROCUREMENT<$50K 60 | 19,739.67 | MAHONEY K | 1 | 1 | MIKE S |  |  | 12-037F |  |  |  |  |  |  |  |  |  |  |  |  |  |  |  |  |  |  |  |  |  |  |  |  |  |  |  |
| 13643095 |  | Proc Matrl's for Beam Stoppers & Diffusers (PSS) |  | 40d | 2012-01-05 | 2012-03-02 | 121643140, 9-120M FS+60d | 453d | 0d |  | MECH TECH [40 h]; PROCUREMENT<$50K 60; ELEC ENG [80 h] | 21,310.38 | MAHONEY K | 1 | 1 | MIKE S |  |  | 12-037F |  |  |  |  |  |  |  |  |  |  |  |  |  |  |  |  |  |  |  |  |  |  |  |  |  |  |  |
| 13643110 |  | Proc PSS Beam Current Monitor Compnts |  | 130d | 2012-01-05 | 2012-07-10 | 9-120M FS+60d, 121643140 | 385d | 0d |  | ELEC ENG [80 h]; PROCUREMENT<$50K 60 | 20,141.18 | MAHONEY K | 1 | 1 | MIKE S |  |  | 12-037F |  |  |  |  |  |  |  |  |  |  |  |  |  |  |  |  |  |  |  |  |  |  |  |  |  |  |  |
| 13643135 |  | Install & Test ODH Monitoring Sys (PSS) |  | 30d | 2012-01-05 | 2012-02-16 | 16333030, 13643130, 16332010U | 415d | 0d |  | COMP SCIENT [40 h]; ELEC TECH [120 h] | 7,920.4 | MAHONEY K | 1 | 1 | MIKE S |  |  | 12-037F |  |  |  |  |  |  |  |  |  |  |  |  |  |  |  |  |  |  |  |  |  |  |  |  |  |  |  |
| 13643150 |  | Proc Equipment for H-A, B, C Upgrades (PSS) |  | 30d | 2012-01-05 | 2012-02-16 | 9-120M FS+60d, 121643140, 2-02M FS-175d | 373d | 341d |  | PROCUREMENT<$50K 60 | 7,242.34 | MAHONEY K | 1 | 1 | MIKE S |  |  | 12-037F |  |  |  |  |  |  |  |  |  |  |  |  |  |  |  |  |  |  |  |  |  |  |  |  |  |  |  |
| 13643025 |  | Test/QA PLC Systems (PSS) |  | 30d | 2012-01-06 | 2012-02-17 | 13643020b FS-232d, 13643020 | 494d | 59d |  | ELEC TECH [102.64 h]; ELEC ENG [136.85 h] | 14,185.64 | MAHONEY K | 1 | 1 | MIKE S |  |  | 12-037F |  |  |  |  |  |  |  |  |  |  |  |  |  |  |  |  | 10-031 |  |  | 10-064 |  |  |  |  |  |  |  |
| 13643045 |  | Install Linac Cable Conduit, Infrastructure (PSS) FY12 |  | 176d | 2012-01-23 | 2012-09-28 | 13643040c, 13643040b, 3A-07M, 16332030, 16331030, 16331032 | 174d | 0d |  | ELEC TECH [567.85 h]; ELEC DES [56.79 h]; SKLLD TRADE [369.1 h]; PLABOR | 121,404.93 | MAHONEY K | 1 | 1 | MIKE S |  |  |  |  |  |  |  |  |  |  |  |  |  |  |  |  |  |  |  | 10-031 |  | 12-018F |  |  |  | 12-053 |  | 11-044 | 10-059 |  |
| 13643165 |  | Install & Test PSS Logic Programs |  | 100d | 2012-01-23 | 2012-06-13 | 13643085, 13643160, 13643090 | 454d | 393d |  | ELEC TECH [32.97 h]; ELEC ENG [131.89 h] | 10,761.13 | MAHONEY K | 1 | 1 | MIKE S |  |  | 12-037F |  |  |  |  |  |  |  |  |  |  |  |  |  |  |  |  | 10-031 |  |  |  |  |  |  |  | 11-044 | 10-059 |  |
| 13643140 |  | Upgrade MCC Console (PSS) |  | 5d | 2012-02-17 | 2012-02-24 | 13643135 | 530d | 469d |  | ELEC TECH [120 h]; ELEC ENG [20 h] | 6,706.8 | MAHONEY K | 1 | 1 | MIKE S |  |  | 12-037F |  |  |  |  |  |  |  |  |  |  |  |  |  |  |  |  |  |  |  |  |  |  |  |  |  |  |  |
| 13643015 |  | PSS Cable Plant Installtn (Contract Oversight) |  | 20d | 2012-03-05 | 2012-03-30 | 16331032, 16331030, 16332030, 13643014 | 312d | 167d |  | ELEC TECH [40 h]; ELEC ENG [80 h] | 7,410 | MAHONEY K | 1 | 1 | MIKE S |  |  | 12-037F |  |  |  |  |  |  |  |  |  |  |  |  |  |  |  |  |  |  | 12-018F |  |  |  |  |  |  |  |  |
| 13643065 |  | Fab & Test Beam Transport Monitor (PSS) |  | 30d | 2012-03-05 | 2012-04-13 | 13643060, 32-03M | 471d | 267d |  | ELEC TECH [80 h] | 3,530.4 | MAHONEY K | 1 | 1 | MIKE S |  |  | 12-037F |  |  |  |  |  |  |  |  |  |  |  |  |  |  |  |  |  |  |  |  |  |  |  |  |  |  |  |
| 13643100 |  | Fab & Test Beam Stoppers & Diffusers (PSS) |  | 50d | 2012-03-05 | 2012-05-11 | 13643095 | 453d | 242d |  | MECH DES [40 h]; MECH TECH [200 h]; MSHOP; ELEC ENG [120 h]; ELEC TECH [80 h]; COMP SCIENT [80 h] | 41,341.56 | MAHONEY K | 1 | 1 | MIKE S |  |  | 12-037F |  |  |  |  |  |  |  |  |  |  |  |  |  |  |  |  |  |  |  |  |  |  |  |  |  |  |  |
| 13643080 |  | Upgrade Existing PLC Sys in Linacs (PSS) |  | 40d | 2012-05-14 | 2012-07-10 | 13643025, 13643025a, 2-02M | 435d | 82d |  | ELEC TECH [160 h]; ELEC ENG [160 h] | 18,350.4 | MAHONEY K | 1 | 1 | MIKE S |  |  | 12-037F |  |  |  |  |  |  |  |  |  |  |  |  |  |  |  |  | 10-031 |  |  | 10-064 |  |  |  |  |  |  |  |
| 13643115 |  | Test/QA PSS Beam Current Monitor Compnts |  | 20d | 2012-07-11 | 2012-08-07 | 13643110 | 385d | 0d |  | ELEC ENG [80 h]; ELEC TECH [40 h] | 7,410 | MAHONEY K | 1 | 1 | MIKE S |  |  | 12-037F |  |  |  |  |  |  |  |  |  |  |  |  |  |  |  |  |  |  |  |  |  |  |  |  |  |  |  |
| 13643215 |  | Tagger ODH Management Oversight FY12 |  | 42d | 2012-08-01 | 2012-09-28 | 9-120M FS+205d | 344d | 0d |  | ELEC ENG [1.09 h]; SCIENTIST [6.55 h] | 539.41 | MAHONEY K | 1 | 1 | MIKE S |  |  | 12-037 |  |  |  |  |  |  |  |  |  |  |  |  |  |  |  |  |  |  | 12-018F |  |  |  | 12-053 |  |  |  | 12-045 |

Notes:
- 13642020: Entry Criteria: Ext Pred: BOD Tagger Bldg, / Tagger Magnet Installed and Operational
- 23642913LOE: BOE NOTES: Demands for management reports such as this were not in estimate.
- 23642014: Steps: Procure BELS Cable and Connectors; Procure BELS - EPICS Interface Components; Procure BELS Communication Components / BOE NOTES: Model Has recent price increase.
- 23642019: Steps: Finalize Documentation; Procure EPICS Interface Components; Procure BCM Interface Components (BSY) / BOE NOTES: Model Has recent price increase.
- 23642914LOE: BOE NOTES: Based on experience supporting 12GeV project. Addition is due to extending effort in to Fy14.
- 23642005: Steps: Program Development; Design Review; Program Test; EPICS Interface Development
- 23642015: Steps: Test BELS Current Transducers; Test BELS PLC Systems; Test BELS Rack Components; Test BELS Communication Components
- 23642020: Entry Criteria: Ext Pred: BOD Tagger Bldg, / Tagger Magnet Installed and Operational / Steps: Finalize Documentation; Install Tagger Electronics; Tagger Cabinet and Field Wiring; Install Tagger - EPICS Interface; Install BSY Hall D Interface Electronics; Install Hall D BCM Interface; As-Built Documentation
- 13643075: Entry Criteria: Ext Pred: Arc 10 Box supplies / installed, new CMs installed
- 13643085: Entry Criteria: Ext Pred: BOD Tagger / Bldg
- 13643090: Entry Criteria: Ext Pred: BOD Hall D
- 13643135: Entry Criteria: Ext Pred: BOD Tagger Bldg, BOD / Tunnel Ext
- 13643015: Entry Criteria: Ext Pred: BOD Tagger Bldg, BOD / Hall D

| ID | Activity | Type | Duration | Start | Finish | Predecessors | Total float | Free float | Calendar | Resources | Cost | RESP - Responsibility | STRT%COMP for CM EVM | FNSH%COMP for CM EVM | CAM RESPONSIBLE | CR 12-018 | CR 12-037 | CR 12-045 | CR 12-053 | CR 10-031 | CR 12-001 | CR 10-059 | CR 11-044 | CR 13-014 | CR 10-064 | CR 13-003 | Milestone Level | ReBaseline Actuals Adjustment | Original Activity ID Rebaseline | Over Under Fixed | EVMS Reporting Codes | Activities with Steps | BOE Procurement | CR 13-015 | Post Rebaseline | Obligated Prior to Rebaseline | BOE Labor | BOE Expenses | CR 14-001 |
| --- | --- | --- | --- | --- | --- | --- | --- | --- | --- | --- | --- | --- | --- | --- | --- | --- | --- | --- | --- | --- | --- | --- | --- | --- | --- | --- | --- | --- | --- | --- | --- | --- | --- | --- | --- | --- | --- | --- | --- |
| 13643220 | Change Control Process |  | 8d | 2012-08-01 | 2012-08-10 | 9-120M FS+205d | 412d | 68d |  | SCIENTIST [4 h]; ELEC ENG [4 h] | 564.68 | MAHONEY K | 1 | 1 | MIKE S | 12-018F | 12-037 | 12-045 |  |  |  |  |  |  |  |  |  |  |  |  |  |  |  |  |  |  |  |  |  |
| 13643225 | Design 5C Line ODH Monitoring |  | 11d | 2012-08-01 | 2012-08-15 | 9-120M FS+205d | 344d | 0d |  | ELEC ENG [60 h]; ELEC TECH [20 h]; ELEC DES [12 h] | 5,722.32 | MAHONEY K | 1 | 1 | MIKE S | 12-018F | 12-037 | 12-045 |  |  |  |  |  |  |  |  |  |  |  |  |  |  |  |  |  |  |  |  |  |
| 13643230 | Design HD Tagger ODH Monitoring |  | 11d | 2012-08-01 | 2012-08-15 | 9-120M FS+205d | 344d | 0d |  | ELEC TECH [20 h]; ELEC DES [8 h]; ELEC ENG [30 h] | 3,403.48 | MAHONEY K | 1 | 1 | MIKE S | 12-018F | 12-037 | 12-045 |  |  |  |  |  |  |  |  |  |  |  |  |  |  |  |  |  |  |  |  |  |
| 13643120 | Install & Test PSS Beam Current Monitor |  | 30d | 2012-08-08 | 2012-09-19 | 16333030, 13643115 | 385d | 324d |  | ELEC TECH [120 h]; ELEC ENG [40 h]; MECH TECH [80 h]; COMP SCIENT [80 h] | 16,922.8 | MAHONEY K | 1 | 1 | MIKE S |  | 12-037F |  |  |  |  |  |  |  |  |  |  |  |  |  |  |  |  |  |  |  |  |  |  |
| 13643240 | 5 C Line ODH Procurements |  | 37d | 2012-08-08 | 2012-09-28 | 13643235 FS-7d | 362d | 0d |  | ELEC ENG [5 h]; ELEC TECH [5 h]; PROCUREMENT<$50K 60 | 7,573.45 | MAHONEY K | 1 | 1 | MIKE S | 12-018F | 12-037 | 12-045 |  |  |  |  |  |  |  |  |  |  |  |  |  |  |  |  |  |  |  |  |  |
| 13643255 | Hall D ODH Procurements |  | 37d | 2012-08-08 | 2012-09-28 | 13643235 FS-7d | 344d | 0d |  | ELEC TECH [5 h]; ELEC ENG [5 h]; PROCUREMENT<$50K 60 | 18,573.45 | MAHONEY K | 1 | 1 | MIKE S | 12-018F | 12-037 | 12-045 |  |  |  |  |  |  |  |  |  |  |  |  |  |  |  |  |  |  |  |  |  |
| 13643235 | Design Review (Internal) |  | 1d | 2012-08-16 | 2012-08-16 | 13643230, 13643225 | 344d | 0d |  | ELEC ENG [32 h] | 2,257.92 | MAHONEY K | 1 | 1 | MIKE S | 12-018F | 12-037 | 12-045 |  |  |  |  |  |  |  |  |  |  |  |  |  |  |  |  |  |  |  |  |  |
| 13643245 | 5 C Line ODH Installation FY12 |  | 26d | 2012-08-23 | 2012-09-28 | 13643240 FS-26d | 362d | 0d |  | ELEC ENG [2.48 h]; ELEC TECH [37.14 h]; SKLLD TRADE [14.86 h] | 2,311.05 | MAHONEY K | 1 | 1 | MIKE S | 12-018F | 12-037 | 12-045 | 12-053 |  |  |  |  |  |  |  |  |  |  |  |  |  |  |  |  |  |  |  |  |
| 13643270 | QA Equipment FY12 |  | 15d | 2012-09-10 | 2012-09-28 | 13643235 FS+15d | 358d | 0d |  | ELEC ENG [2.57 h]; ELEC TECH [6.86 h]; SUPPLIES & MATERIALS | 569.78 | MAHONEY K | 1 | 1 | MIKE S | 12-018F | 12-037 | 12-045 | 12-053 |  |  |  |  |  |  |  |  |  |  |  |  |  |  |  |  |  |  |  |  |
| 13643275 | Modify PSS Racks FY12 |  | 6d | 2012-09-21 | 2012-09-28 | 9-120M FS+241d | 372d | 0d |  | ELEC ENG [1 h]; ELEC TECH [12 h]; SUPPLIES & MATERIALS | 700.12 | MAHONEY K | 1 | 1 | MIKE S | 12-018F | 12-037 | 12-045 | 12-053 |  |  |  |  |  |  |  |  |  |  |  |  |  |  |  |  |  |  |  |  |
| 13643280 | EPICS Interface Development FY12 |  | 6d | 2012-09-21 | 2012-09-28 | 9-120M FS+241d | 364d | 0d |  | ELEC ENG [2.27 h]; COMP SCIENT [11.34 h] | 904.3 | MAHONEY K | 1 | 1 | MIKE S | 12-018F | 12-037 | 12-045 | 12-053 |  |  |  |  |  |  |  |  |  |  |  |  |  |  |  |  |  |  |  |  |
| 13643035abb | Test/QA Custom Compnts for RF Installation (PSS) FY13 |  | 25d | 2012-10-01 | 2012-11-02 | 13643035ab | 173d | 28d |  | ELEC TECH [4.46 h] | 203.11 | MAHONEY K | 1 | 1 | MIKE S | 12-018F |  |  | 12-053 | 10-031 | 12-001 |  |  |  |  |  |  |  |  |  |  |  |  |  |  |  |  |  |  |
| 13643035ba | Test/QA Custom Compnts (PSS) FY13 |  | 25d | 2012-10-01 | 2012-11-02 | 13643035b | 173d | 28d |  | ELEC TECH [12.24 h] | 557.41 | MAHONEY K | 1 | 1 | MIKE S | 12-018F |  |  | 12-053 | 10-031 | 12-001 |  |  |  |  |  |  |  |  |  |  |  |  |  |  |  |  |  |  |
| 13643045b | Install Linac Cable Conduit, Infrastructure (PSS) FY13 |  | 24d | 2012-10-01 | 2012-11-01 | 13643045 | 174d | 29d |  | ELEC TECH [77.43 h]; ELEC DES [7.74 h]; SKLLD TRADE [50.33 h]; PLABOR | 17,083.17 | MAHONEY K | 1 | 1 | MIKE S | 12-018F |  |  | 12-053 | 10-031 |  | 10-059 | 11-044 |  |  |  |  |  |  |  |  |  |  |  |  |  |  |  |  |
| 13643215a | Tagger ODH Management Oversight FY13 |  | 35d | 2012-10-01 | 2012-11-16 | 13643215 | 344d | 0d |  | ELEC ENG [0.91 h]; SCIENTIST [5.45 h] | 463.35 | MAHONEY K | 1 | 1 | MIKE S | 12-018F | 12-037 | 12-045 | 12-053 |  |  |  |  |  |  |  |  |  |  |  |  |  |  |  |  |  |  |  |  |
| 13643245a | 5 C Line ODH Installation FY13 |  | 16d | 2012-10-01 | 2012-10-22 | 13643245 | 362d | 18d |  | ELEC ENG [1.52 h]; ELEC TECH [22.86 h]; SKLLD TRADE [9.14 h] | 1,467.22 | MAHONEY K | 1 | 1 | MIKE S | 12-018F | 12-037 | 12-045 | 12-053 |  |  |  |  |  |  |  |  |  |  |  |  |  |  |  |  |  |  |  |  |
| 13643260 | Hall D ODH Installation |  | 23d | 2012-10-01 | 2012-10-31 | 13643255 | 344d | 0d |  | ELEC TECH [80 h]; SKLLD TRADE [40 h]; ELEC ENG [4 h] | 5,315.24 | MAHONEY K | 1 | 1 | MIKE S | 12-018F | 12-037 | 12-045 |  |  |  |  |  |  |  |  |  |  |  |  |  |  |  |  |  |  |  |  |  |
| 13643270a | QA Equipment FY13 |  | 20d | 2012-10-01 | 2012-10-26 | 13643270 | 358d | 14d |  | ELEC ENG [3.43 h]; ELEC TECH [9.14 h]; SUPPLIES & MATERIALS | 783.92 | MAHONEY K | 1 | 1 | MIKE S | 12-018F | 12-037 | 12-045 | 12-053 |  |  |  |  |  |  |  |  |  |  |  |  |  |  |  |  |  |  |  |  |
| 13643275a | Modify PSS Racks FY13 |  | 6d | 2012-10-01 | 2012-10-08 | 13643275 | 372d | 28d |  | ELEC ENG [1 h]; ELEC TECH [12 h]; SUPPLIES & MATERIALS | 722.48 | MAHONEY K | 1 | 1 | MIKE S | 12-018F | 12-037 | 12-045 | 12-053 |  |  |  |  |  |  |  |  |  |  |  |  |  |  |  |  |  |  |  |  |
| 13643280a | EPICS Interface Development FY13 |  | 14d | 2012-10-01 | 2012-10-18 | 13643280 | 364d | 20d |  | ELEC ENG [5.73 h]; COMP SCIENT [28.66 h] | 2,357.77 | MAHONEY K | 1 | 1 | MIKE S | 12-018F | 12-037 | 12-045 | 12-053 |  |  |  |  |  |  |  |  |  |  |  |  |  |  |  |  |  |  |  |  |
| 13643913LOE | FY13 Mngmnt & Supprt Effort for PSS |  | 228d | 2012-10-01 | 2013-08-30 | 13643912LOE | 20d |  |  | OFFICE [22.06 h]; SR STAFF [80.9 h]; ELEC ENG [180.19 h]; ELEC DES [364.07 h] | 42,178.55 | MAHONEY K | 1 | 1 | MIKE S |  |  |  |  |  |  |  |  | 13-014 |  |  |  |  |  |  |  |  |  |  |  |  |  |  |  |
| 13643320 | Program Local Electronics |  | 20d | 2012-10-19 | 2012-11-15 | 13643260 FS-9d | 344d | 0d |  | ELEC ENG [40 h] | 2,912.4 | MAHONEY K | 1 | 1 | MIKE S | 12-018F | 12-037 | 12-045 |  |  |  |  |  |  |  |  |  |  |  |  |  |  |  |  |  |  |  |  |  |
| 13643325 | Install Local Alarms |  | 20d | 2012-10-19 | 2012-11-15 | 13643260 FS-9d | 344d | 0d |  | ELEC TECH [16 h] | 728.64 | MAHONEY K | 1 | 1 | MIKE S | 12-018F | 12-037 | 12-045 |  |  |  |  |  |  |  |  |  |  |  |  |  |  |  |  |  |  |  |  |  |
| 13643330 | Install Alarm Segment Interface |  | 15d | 2012-10-26 | 2012-11-15 | 13643325 FS-15d | 344d | 0d |  | ELEC TECH [8 h] | 364.32 | MAHONEY K | 1 | 1 | MIKE S | 12-018F | 12-037 | 12-045 |  |  |  |  |  |  |  |  |  |  |  |  |  |  |  |  |  |  |  |  |  |
| 13643020b | Proc Remaining Cable and PLC Systems |  | 23d | 2012-11-01 | 2012-12-05 | 9-130M FS+23d | 494d | 0d |  | PROCUREMENT<$50K 60 | 55,000 | MAHONEY K | 1 | 1 | MIKE S |  | 12-037F |  |  | 10-031 |  |  |  |  | 10-064 | 13-003 |  |  |  |  |  |  |  |  |  |  |  |  |  |
| 13643137 | Complete the Install & Test of ODH Monitoring Sys (PSS) |  | 25d | 2012-11-01 | 2012-12-07 | 9-130M FS+23d | 210d | 65d |  | ELEC TECH [42.2 h]; ELEC ENG [39.5 h] | 4,797.79 | MAHONEY K | 1 | 1 | MIKE S |  | 12-037F |  |  |  |  |  |  |  |  | 13-003 |  |  |  |  |  |  |  |  |  |  |  |  |  |
| 13643335 | Software Checkout |  | 11d | 2012-11-01 | 2012-11-15 | 13643320 FS-11d | 344d | 0d |  | ELEC ENG [8 h]; COMP SCIENT [8 h]; ELEC TECH [4 h] | 1,306.32 | MAHONEY K | 1 | 1 | MIKE S | 12-018F | 12-037 | 12-045 |  |  |  |  |  |  |  |  |  |  |  |  |  |  |  |  |  |  |  |  |  |
| 13643350 | PSS PLC Communications - Labor |  | 171d | 2012-11-01 | 2013-07-15 | 9-130M FS+23d | 95d | 0d |  | ELEC ENG [115.4 h]; ELEC TECH [46 h] | 10,497.11 | MAHONEY K | 1 | 1 | MIKE S | 12-018F | 12-037 | 12-045 |  |  |  |  |  |  |  | 13-003 |  |  |  |  |  |  |  |  |  |  |  |  |  |
| 13643170M | Linac PSS Systems Comp | milestone | 0d | 2012-11-02 | 2012-11-02 | 13643080, 13458050 | 353d | 292d |  |  |  | MAHONEY K | 1 | 1 | MIKE S |  | 12-037F |  |  | 10-031 |  |  |  |  | 10-064 |  | 6 |  |  |  |  |  |  |  |  |  |  |  |  |
| 13643340 | Test and Commission |  | 4d | 2012-11-12 | 2012-11-15 | 13643325 FS-4d | 344d | 0d |  | ELEC TECH [8 h]; ELEC ENG [8 h]; COMP SCIENT [2 h] | 1,082.22 | MAHONEY K | 1 | 1 | MIKE S | 12-018F | 12-037 | 12-045 |  |  |  |  |  |  |  |  |  |  |  |  |  |  |  |  |  |  |  |  |  |
| 13643360 | C-100 RF Commissioning PSS Support |  | 192d | 2012-11-13 | 2013-08-23 | 9-130M FS+31d | 14d |  |  | ELEC ENG [55 h]; ELEC TECH [351 h] | 19,989.09 | MAHONEY K | 1 | 1 | MIKE S | 12-018F | 12-037 | 12-045 |  |  |  |  |  |  |  | 13-003 |  |  |  |  |  |  |  |  |  |  |  |  |  |
| 13643345 | 5C Line ODH Extension Complete | milestone | 0d | 2012-11-16 | 2012-11-16 | 13643220, 13643340, 13643215a FS-1d, 13643270a, 13643330, 13643275a, 13643235 FS-7d, 13643245a, 13643255, 13643280a, 13643335 | 344d | 283d |  |  |  | MAHONEY K | 1 | 1 | MIKE S | 12-018F | 12-037 | 12-045 |  |  |  |  |  |  |  |  |  |  |  |  |  |  |  |  |  |  |  |  |  |
| 13643210 | Cable Plant - Field Termination (PSS) |  | 13d | 2012-11-28 | 2012-12-14 | 13643015, 9-130M FS+40d | 145d | 0d |  | ELEC ENG [40 h]; ELEC TECH [80 h]; PLABOR | 24,241.77 | MAHONEY K | 1 | 1 | MIKE S | 12-018F | 12-037 |  |  |  |  |  |  |  |  |  |  |  |  |  |  |  |  |  |  |  |  |  |  |
| 13643145 | Install & Test Access Control Sys (PSS) |  | 60d | 2012-12-17 | 2013-03-20 | 16331030, 16333030, 16331032, 13643035abb, 13643035ba, 13643055, 13643045b, 13643210, 16332030 | 145d | 0d |  | ELEC TECH [400 h]; ELEC ENG [240 h] | 35,690.4 | MAHONEY K | 1 | 1 | MIKE S | 12-018F | 12-037 |  |  |  |  |  |  |  |  |  |  |  |  |  |  |  |  |  |  |  |  |  |  |
| 13643205 | Install Public Address Sys (PSS) |  | 30d | 2012-12-17 | 2013-02-05 | 16332030, 16331030, 16333030, 16331032, 16332010U, 13643210 | 175d | 30d |  | ELEC ENG [40 h]; ELEC TECH [160 h] | 10,198.8 | MAHONEY K | 1 | 1 | MIKE S | 12-018F | 12-037 |  |  |  |  |  |  |  |  |  |  |  |  |  |  |  |  |  |  |  |  |  |  |
| 13643355 | PSS PLC Communications - Procurements |  | 62d | 2013-02-01 | 2013-04-30 | 13643350 FS-114d | 95d |  |  | PROCUREMENT<$50K 60 | 9,500 | MAHONEY K | 1 | 1 | MIKE S | 12-018F | 12-037 | 12-045 |  |  |  |  |  |  |  | 13-003 |  |  |  |  |  |  |  |  |  |  |  |  |  |
| 13643180M | Tagger Bldng PSS Systems Comp | milestone | 0d | 2013-03-20 | 2013-03-20 | 13643145, 13643135, 13643137 | 145d | 0d |  |  |  | MAHONEY K | 1 | 1 | MIKE S | 12-018F | 12-037 |  |  |  |  |  |  |  |  |  | 6 |  |  |  |  |  |  |  |  |  |  |  |  |
| 13643185M | H-D PSS Systems Comp | milestone | 0d | 2013-03-20 | 2013-03-20 | 13643180M, 16332030, 13643145, 13643205 | 145d |  |  |  |  | MAHONEY K | 1 | 1 | MIKE S | 12-018F | 12-037 |  |  |  |  |  |  |  |  |  | 6 |  |  |  |  |  |  |  |  |  |  |  |  |
| 13643105 | Install Beam Stoppers & Diffusers (PSS) |  | 22d | 2013-05-06 | 2013-06-05 | 13643210, 16333030, 13643100, 9-130M FS+145d | 211d | 150d |  | MECH TECH [80 h] | 3,668.8 | MAHONEY K | 1 | 1 | MIKE S |  | 12-037 |  |  |  |  |  |  |  |  |  |  |  |  |  |  |  |  |  |  |  |  |  |  |
| 13643070 | Install Beam Transport Monitor (PSS) |  | 24d | 2013-05-13 | 2013-06-14 | 9-130M FS+150d, 13643065, 13643210 | 204d | 143d |  | ELEC TECH [80 h]; COMP SCIENT [160 h]; ELEC ENG [120 h] | 23,214 | MAHONEY K | 1 | 1 | MIKE S |  | 12-037 |  |  |  |  |  |  |  |  |  |  |  |  |  |  |  |  |  |  |  |  |  |  |
| 13643155 | Install & Test H-A, B, C Upgrades (PSS) |  | 42d | 2013-07-01 | 2013-08-28 | 13643150, 2-02M, 9-130M FS+184d | 32d | 0d |  | ELEC ENG [40 h]; ELEC TECH [120 h] | 8,377.2 | MAHONEY K | 1 | 1 | MIKE S |  | 12-037 |  |  |  |  |  |  |  |  |  |  |  |  |  |  |  |  |  |  |  |  |  |  |
| 13643175M | Halls A, B, C PSS Systems Comp | milestone | 0d | 2013-08-28 | 2013-08-28 | 13643155 | 32d |  |  |  |  | MAHONEY K | 1 | 1 | MIKE S |  | 12-037 |  |  |  |  |  |  |  |  |  | 6 |  |  |  |  |  |  |  |  |  |  |  |  |
| 13643950 | Re-Baseline Actuals Adjustment |  | 1d | 2013-08-30 | 2013-08-30 | 9-130M FS+227d | 20d |  |  | PROCUREMENT>$50K 69 NO ESCALATION | 219,696.91 | MAHONEY K | 1 | 1 | MIKE S |  |  |  |  |  |  |  |  | 13-014 |  |  |  | ADJ |  |  |  |  |  |  |  |  |  |  |  |
| 23643020b | Proc Remaining Cable and PLC Systems |  | 43d | 2013-09-03 | 2013-10-31 | 9-130M FS+228d | 76d | 0d | 8/5 M-F w/JLAB Holidays ReBaseline | PROCUREMENT<$50K 60 NO ESCALATION FY14; PROCUREMENT>$50K 69 NO ESCALATION | 4,278.8 | MAHONEY K | 1 | 1 | MIKE S |  | 12-037F |  |  | 10-031 |  |  |  |  | 10-064 | 13-003 |  |  | 23643020b | y | S | ST | CP | 13-015 | PR | OB |  |  |  |
| 23643045 | Install Linac Cable Conduit, Infrastructure (PSS) FY13 |  | 20d | 2013-09-03 | 2013-09-30 | 23643020b FS-43d | 76d | 0d | 8/5 M-F w/JLAB Holidays ReBaseline | ELEC TECH [36.3 h]; ELEC DES [3.63 h]; SKLLD TRADE [23.59 h]; PLABOR | 4,797.11 | MAHONEY K | 1 | 1 | MIKE S | 12-018F |  |  | 12-053 | 10-031 |  | 10-059 | 11-044 |  |  |  |  |  | 23643045 |  | S | ST |  | 13-015 | PR |  | PE | EV |  |
| 23643100 | Fab & Test Beam Stoppers & Diffusers (PSS) FY13 |  | 20d | 2013-09-03 | 2013-09-30 | 9-130M FS+228d | 112d | 0d | 8/5 M-F w/JLAB Holidays ReBaseline | MECH DES [23.33 h]; MECH TECH [116.67 h]; MSHOP; ELEC ENG [70 h]; ELEC TECH [46.67 h] | 21,793.99 | MAHONEY K | 1 | 1 | MIKE S |  | 12-037F |  |  |  |  |  |  |  |  |  |  |  | 23643100 |  | S | ST | PE | 13-015 | PR |  | PE | PE |  |
| 23643117 | Proc BCM Cavity Components- (PSS) Procurement |  | 43d | 2013-09-03 | 2013-10-31 | 9-130M FS+228d | 106d | 44d | 8/5 M-F w/JLAB Holidays ReBaseline | PROCUREMENT<$50K 60 NO ESCALATION FY14 | 6,751.92 | MAHONEY K | 1 | 1 | MIKE S |  | 12-037F |  |  |  |  |  |  |  |  |  |  |  | 23643117 | y | S | ST | PE | 13-015 | PR | OB |  | PE |  |
| 23643117a | Proc BCM Cavity Components- (PSS) Expenses FY13 |  | 20d | 2013-09-03 | 2013-09-30 | 9-130M FS+228d | 105.5d | 0d | 8/5 M-F w/JLAB Holidays ReBaseline | MSHOP | 465.12 | MAHONEY K | 1 | 1 | MIKE S |  | 12-037F |  |  |  |  |  |  |  |  |  |  |  | 23643117 |  | S | ST | PE | 13-015 | PR |  |  | PE |  |
| 23643140 | Upgrade MCC Console (PSS) FY13 |  | 20d | 2013-09-03 | 2013-09-30 | 9-130M FS+228d | 118d | 0d | 8/5 M-F w/JLAB Holidays ReBaseline | ELEC TECH [69.68 h]; ELEC ENG [11.61 h] | 4,018.63 | MAHONEY K | 1 | 1 | MIKE S |  | 12-037F |  |  |  |  |  |  |  |  |  |  |  | 23643140 |  | S | ST |  | 13-015 | PR |  | PE |  |  |
| 23643360 | C-100 RF Commissioning PSS Support |  | 20d | 2013-09-03 | 2013-09-30 | 9-130M FS+228d | 30d | 0d | 8/5 M-F w/JLAB Holidays ReBaseline | ELEC ENG [8.25 h]; ELEC TECH [52.65 h] | 2,998.36 | MAHONEY K | 1 | 1 | MIKE S | 12-018F | 12-037 | 12-045 |  |  |  |  |  |  |  | 13-003 |  |  | 23643360 |  | S | ST |  | 13-015 | PR |  | PE |  |  |
| 23643913LOE | FY13 Mngmnt & Supprt Effort for PSS |  | 20d | 2013-09-03 | 2013-09-30 | 9-130M FS+228d | 142d | 0d | 8/5 M-F w/JLAB Holidays ReBaseline | OFFICE [1.94 h]; ELEC ENG [15.8 h]; ELEC DES [31.93 h]; SCIENTIST [8.05 h] | 3,458.49 | MAHONEY K | 1 | 1 | MIKE S |  |  |  |  |  |  |  |  |  |  |  |  |  | 23643913LOE |  | E |  |  | 13-015 | PR |  | PE |  |  |
| 23643105 | Install Beam Stoppers & Diffusers (PSS) FY13 |  | 11d | 2013-09-16 | 2013-09-30 | 23643100a FS-20d, 23643102 FS-68d, 23643100 FS-20d | 107d | 0d | 8/5 M-F w/JLAB Holidays ReBaseline | MECH TECH [26.67 h] | 1,223.09 | MAHONEY K | 1 | 1 | MIKE S |  | 12-037 |  |  |  |  |  |  |  |  |  |  |  | 23643105 |  | S | ST |  | 13-015 | PR |  | PE |  |  |
| 23643145 | Install & Test Tagger Access Control Sys (PSS) FY13 |  | 11d | 2013-09-16 | 2013-09-30 | 23643045 FS-23d, 23643045a FS-23d | 87d | 0d | 8/5 M-F w/JLAB Holidays ReBaseline | ELEC TECH [39.52 h]; ELEC ENG [11.62 h]; ELEC DES [5.81 h] | 2,948.68 | MAHONEY K | 1 | 1 | MIKE S | 12-018F | 12-037 |  |  |  |  |  |  |  |  |  |  |  | 23643145 |  | S | ST |  | 13-015 | PR |  | PE |  |  |
| 23643145b | Install & Test Hall D-MCC Access Control Sys (PSS) FY13 |  | 11d | 2013-09-16 | 2013-09-30 | 23643045 FS-23d, 23643045a FS-23d | 76d | 0d | 8/5 M-F w/JLAB Holidays ReBaseline | ELEC TECH [37.4 h]; ELEC ENG [11 h]; ELEC DES [5.5 h] | 2,790.77 | MAHONEY K | 1 | 1 | MIKE S | 12-018F | 12-037 |  |  |  |  |  |  |  |  |  |  |  | 23643145b |  | S | ST |  | 13-015 | PR |  | PE |  |  |
| 23643350 | PSS PLC Communications - Labor FY13 |  | 11d | 2013-09-16 | 2013-09-30 | 9-130M FS+237d | 6d | 0d | 8/5 M-F w/JLAB Holidays ReBaseline | ELEC ENG [16.39 h]; ELEC TECH [6.54 h] | 1,491.31 | MAHONEY K | 1 | 1 | MIKE S | 12-018F | 12-037 | 12-045 |  |  |  |  |  |  |  | 13-003 |  |  | 23643350 |  | S | ST |  | 13-015 | PR |  | EJ |  |  |
| 23643170M | Linac PSS Systems Comp | milestone | 0d | 2013-09-30 | 2013-09-30 | 23643360 | 30d | 19d | 8/5 M-F w/JLAB Holidays ReBaseline |  |  | MAHONEY K | 1 | 1 | MIKE S |  | 12-037F |  |  | 10-031 |  |  |  |  | 10-064 |  | 6 |  | 23643170M |  | M |  |  | 13-015 | PR |  |  |  |  |
| 23643045a | Install Linac Cable Conduit, Infrastructure (PSS) FY14 |  | 12d | 2013-10-01 | 2013-10-16 | 23643020b FS-43d, 23643045 | 76d | 0d | 8/5 M-F w/JLAB Holidays ReBaseline | ELEC TECH [21.78 h]; ELEC DES [2.18 h]; SKLLD TRADE [14.16 h]; PLABOR | 2,969.91 | MAHONEY K | 1 | 1 | MIKE S | 12-018F |  |  | 12-053 | 10-031 |  | 10-059 | 11-044 |  |  |  |  |  | 23643045 |  | S | ST |  | 13-015 | PR |  | PE | EV | 14-001 |
| 23643100a | Fab & Test Beam Stoppers & Diffusers (PSS) FY14 |  | 4d | 2013-10-01 | 2013-10-04 | 9-130M FS+228d, 23643100 | 112d | 5d | 8/5 M-F w/JLAB Holidays ReBaseline | MECH DES [4.67 h]; MECH TECH [23.33 h]; MSHOP; ELEC ENG [14 h]; ELEC TECH [9.33 h] | 4,497.49 | MAHONEY K | 1 | 1 | MIKE S |  | 12-037F |  |  |  |  |  |  |  |  |  |  |  | 23643100 |  | S | ST | PE | 13-015 | PR |  | PE | PE | 14-001 |
| 23643105a | Install Beam Stoppers & Diffusers (PSS) FY14 |  | 22d | 2013-10-01 | 2013-10-30 | 23643105, 23643100 FS-20d, 23643102 FS-68d, 23643100a FS-20d | 107d | 45d | 8/5 M-F w/JLAB Holidays ReBaseline | MECH TECH [53.33 h] | 2,523.58 | MAHONEY K | 1 | 1 | MIKE S |  | 12-037 |  |  |  |  |  |  |  |  |  |  |  | 23643105 |  | S | ST |  | 13-015 | PR |  | PE |  | 14-001 |
| 23643117b | Proc BCM Cavity Components- (PSS) Expenses FY14 |  | 23.5d | 2013-10-01 | 2013-11-01 | 9-130M FS+228d, 23643117a | 105.5d | 43.5d | 8/5 M-F w/JLAB Holidays ReBaseline | MSHOP | 551.94 | MAHONEY K | 1 | 1 | MIKE S |  | 12-037F |  |  |  |  |  |  |  |  |  |  |  | 23643117 |  | S | ST | PE | 13-015 | PR |  |  | PE | 14-001 |
| 23643140a | Upgrade MCC Console (PSS) FY14 |  | 11d | 2013-10-01 | 2013-10-15 | 23643140, 9-130M FS+228d | 118d | 56d | 8/5 M-F w/JLAB Holidays ReBaseline | ELEC TECH [38.32 h]; ELEC ENG [6.39 h] | 2,280.66 | MAHONEY K | 1 | 1 | MIKE S |  | 12-037F |  |  |  |  |  |  |  |  |  |  |  | 23643140 |  | S | ST |  | 13-015 | PR |  | PE |  | 14-001 |
| 23643145a | Install & Test Tagger Access Control Sys (PSS) FY14 |  | 42d | 2013-10-01 | 2013-11-27 | 23643045 FS-23d, 23643045a FS-23d, 23643145 | 87d | 11d | 8/5 M-F w/JLAB Holidays ReBaseline | ELEC TECH [150.88 h]; ELEC ENG [44.38 h]; ELEC DES [22.19 h] | 11,617.42 | MAHONEY K | 1 | 1 | MIKE S | 12-018F | 12-037 |  |  |  |  |  |  |  |  |  |  |  | 23643145 |  | S | ST |  | 13-015 | PR |  | PE |  | 14-001 |
| 23643145ba | Install & Test Hall D-MCC Access Control Sys (PSS) FY14 |  | 53d | 2013-10-01 | 2013-12-16 | 23643045a FS-23d, 23643045 FS-23d, 23643145b | 76d | 0d | 8/5 M-F w/JLAB Holidays ReBaseline | ELEC TECH [180.2 h]; ELEC ENG [53 h]; ELEC DES [26.5 h] | 13,874.66 | MAHONEY K | 1 | 1 | MIKE S | 12-018F | 12-037 |  |  |  |  |  |  |  |  |  |  |  | 23643145b |  | S | ST |  | 13-015 | PR |  | PE |  | 14-001 |
| 23643350a | PSS PLC Communications - Labor FY14 |  | 42d | 2013-10-01 | 2013-11-27 | 9-130M FS+237d, 23643350 | 6d | 0d | 8/5 M-F w/JLAB Holidays ReBaseline | ELEC ENG [62.59 h]; ELEC TECH [24.95 h] | 5,874.8 | MAHONEY K | 1 | 1 | MIKE S | 12-018F | 12-037 | 12-045 |  |  |  |  |  |  |  | 13-003 |  |  | 23643350 |  | S | ST |  | 13-015 | PR |  | EJ |  | 14-001 |
| 23643914LOE | FY14 Mngmnt & Supprt Effort for PSS |  | 163d | 2013-10-01 | 2014-06-02 | 23643913LOE | 142d |  | 8/5 M-F w/JLAB Holidays ReBaseline | OFFICE [20 h]; ELEC ENG [117.76 h]; ELEC DES [237.92 h]; SCIENTIST [60 h] | 26,761.45 | MAHONEY K | 1 | 1 | MIKE S |  |  |  |  |  |  |  |  |  |  |  |  |  | 23643914LOE |  | E |  |  | 13-015 | PR |  | PE |  | 14-001 |
| 23643355 | PSS PLC Communications - Procurements |  | 21d | 2013-10-03 | 2013-10-31 | 23643350a FS-40d, 23643350 FS-40d | 6d |  | 8/5 M-F w/JLAB Holidays ReBaseline | PROCUREMENT<$50K 60 | 9,803.05 | MAHONEY K | 1 | 1 | MIKE S | 12-018F | 12-037 | 12-045 |  |  |  |  |  |  |  | 13-003 |  |  | 23643355 |  | S | ST | CP | 13-015 | PR |  |  |  | 14-001 |
| 23643065 | Fab & Test Beam Transport Monitor (PSS) |  | 26d | 2013-10-14 | 2013-11-18 | 9-140M FS+9d | 65d | 0d | 8/5 M-F w/JLAB Holidays ReBaseline | ELEC TECH [68 h] | 3,195.32 | MAHONEY K | 1 | 1 | MIKE S |  | 12-037F |  |  |  |  |  |  |  |  |  |  |  | 23643065 |  | S | ST |  | 13-015 | PR |  | PE |  | 14-001 |
| 23643120 | Install & Test PSS Beam Current Monitor |  | 47d | 2013-10-15 | 2013-12-20 | 23643115 FS-43d | 72d | 7d | 8/5 M-F w/JLAB Holidays ReBaseline | ELEC TECH [108 h]; ELEC ENG [36 h]; MECH TECH [72 h]; COMP SCIENT [72 h] | 16,217.28 | MAHONEY K | 1 | 1 | MIKE S |  | 12-037F |  |  |  |  |  |  |  |  |  |  |  | 23643120 |  | S | ST |  | 13-015 | PR |  | PE |  | 14-001 |
| 23643070 | Install Beam Transport Monitor (PSS) |  | 34d | 2013-11-01 | 2013-12-20 | 23643065 FS-12d | 65d | 0d | 8/5 M-F w/JLAB Holidays ReBaseline | ELEC ENG [120 h]; COMP SCIENT [160 h]; ELEC TECH [80 h] | 23,954 | MAHONEY K | 1 | 1 | MIKE S |  | 12-037 |  |  |  |  |  |  |  |  |  |  |  | 23643070 |  | S | ST |  | 13-015 | PR |  | PE |  | 14-001 |
| 23643102 | Update Stopper/Diffuser Software (PSS) |  | 34d | 2013-11-01 | 2013-12-20 | 23643100, 23643100a, 9-140M FS+23d | 107d | 0d | 8/5 M-F w/JLAB Holidays ReBaseline | COMP SCIENT [40 h] | 2,794.8 | MAHONEY K | 1 | 1 | MIKE S |  | 12-037F |  |  |  |  |  |  |  |  |  |  |  | 23643100 |  | S | ST | PE | 13-015 | PR |  | PE | PE | 14-001 |

Notes:
- 13643120: Entry Criteria: Ext Pred: BOD Tunnel / Ext
- 13643245: Steps: Install Conduit and Infrastructure; install and Terminate Cable; Install Oxygen Monitors in 5C Line; Install Electronics for 5C Line
- 13643245a: Steps: Install Conduit and Infrastructure; install and Terminate Cable; Install Oxygen Monitors in 5C Line; Install Electronics for 5C Line
- 13643260: Steps: Install Conduit and Infrastructure; install and Terminate Cable; Install Oxygen Monitors in Hall D; Install Electronics for Hall D Tagger
- 13643137: Entry Criteria: Ext Pred: BOD Tagger Bldg, BOD / Tunnel Ext
- 13643350: Steps: Complete PLC Communications Design Modification; Order Components; Install Components
- 13643340: Steps: Test and Commission Hall D ODH System; (New step)1
- 13643360: Steps: RF Commissioning PSS Support for NL22; RF Commissioning PSS Support for NL23; RF Commissioning PSS Support for NL24; RF Commissioning PSS Support for NL25; RF Commissioning PSS Support for NL26; RF Commissioning PSS Support for SL22; RF Commissioning PSS Support for SL26
- 13643145: Entry Criteria: Ext Pred: BOD Tagger Bldg, Hall / D, Tunnel Ext
- 13643205: Entry Criteria: Ext Pred: BOD Tagger Bldg, Hall / D, Tunnel Ext
- 13643105: Entry Criteria: Ext Pred: BOD Tunnel / Ext
- 13643070: Entry Criteria: Ext Pred: / Magnets Installed
- 23643020b: Steps: Procure Final PLC SW Lic/Module / BOE NOTES: Based on experience to date with Accelerator upgrade, and Hall D ODH systems.
- 23643045: Steps: Install Hall D Local Cable; Install Tagger Local Cable
- 23643100: Steps: Clean/Assemble Parts; Assemble Stopper/Diffusers (3); Test Stoppers in Lab; Fab Switch Panels (3); Final Cleaning and Assembly; Update EPICS Controls; Electrical/Pneumatic Testing / BOE NOTES: Materials Prices volatile
- 23643117: Steps: Machine Shop Fabrication / BOE NOTES: Based on experience with other cavities, and I&C experience with MPS cavities.
- 23643117a: Steps: Machine Shop Fabrication / BOE NOTES: Based on experience with other cavities, and I&C experience with MPS cavities.
- 23643140: Steps: Replace Panels; Install Tagger/Hall D Controls; Wire New Controls; Update Camera Sw. System; Test Console Controls
- 23643360: Steps: RF Commissioning PSS Support for NL26
- 23643913LOE: BOE NOTES: Demands for management reports such as this were not in estimate.
- 23643105: Entry Criteria: Ext Pred: BOD Tunnel / Ext / Steps: Work Prep; Laiason with Stand Integration; Modify Dry Air Controls; Modify Nitrogen Gas Panel; Connect Pneumatics; Leak Test
- 23643145: Entry Criteria: Ext Pred: BOD Tagger Bldg, Hall / D, Tunnel Ext / Steps: Install Vault PSS Equipment; Install Access Room Equipment; Complete Rack Wiring; Complete Field Wiring; Test/QA Components; As-Built Documentation
- 23643145b: Entry Criteria: Ext Pred: BOD Tagger Bldg, Hall / D, Tunnel Ext / Steps: Install Hall D PLC Electronics; Complete MCC Rack Wiring; Complete MCC Field Wiring; Install HD I/O Drop in Injector; Complete Injector Rack Wiring; Complete Injector Field Wiring; System Level Test; As-Built Documentation
- 23643350: Steps: Final Implementation Review; Procurement Labor; Test/Configure Components; Field Test
- 23643045a: Steps: Install Hall D Local Cable; Install Tagger Local Cable
- 23643100a: Steps: Clean/Assemble Parts; Assemble Stopper/Diffusers (3); Test Stoppers in Lab; Fab Switch Panels (3); Final Cleaning and Assembly; Update EPICS Controls; Electrical/Pneumatic Testing / BOE NOTES: Materials Prices volatile
- 23643105a: Entry Criteria: Ext Pred: BOD Tunnel / Ext / Steps: Work Prep; Laiason with Stand Integration; Modify Dry Air Controls; Modify Nitrogen Gas Panel; Connect Pneumatics; Leak Test
- 23643117b: Steps: Machine Shop Fabrication / BOE NOTES: Based on experience with other cavities, and I&C experience with MPS cavities.
- 23643140a: Steps: Replace Panels; Install Tagger/Hall D Controls; Wire New Controls; Update Camera Sw. System; Test Console Controls
- 23643145a: Entry Criteria: Ext Pred: BOD Tagger Bldg, Hall / D, Tunnel Ext / Steps: Install Vault PSS Equipment; Install Access Room Equipment; Complete Rack Wiring; Complete Field Wiring; Test/QA Components; As-Built Documentation
- 23643145ba: Entry Criteria: Ext Pred: BOD Tagger Bldg, Hall / D, Tunnel Ext / Steps: Install Hall D PLC Electronics; Complete MCC Rack Wiring; Complete MCC Field Wiring; Install HD I/O Drop in Injector; Complete Injector Rack Wiring; Complete Injector Field Wiring; System Level Test; As-Built Documentation
- 23643350a: Steps: Final Implementation Review; Procurement Labor; Test/Configure Components; Field Test
- 23643914LOE: BOE NOTES: Based on experience supporting 12GeV project. Addition is due to extending effort in to Fy14.
- 23643355: Steps: Procure Comm. Hardware; Procure PLC Comm. Hardware; Procure Comm. Sec. Software / BOE NOTES: New hardware available that addresses known vulnerabilities.
- 23643065: Steps: Build PLC Components; Test PLC Components; Characterize System
- 23643120: Entry Criteria: Ext Pred: BOD Tunnel / Ext / Steps: Install BCM Electronics; Install RF Electronics; Wire/Cable Hall D BCM Channel; Install Heliax; Install Field Wiring; Test/QA RF Components; Connect BCM and Calibrate / BOE NOTES: Adder due to personnel that engineered BCM is no longer at Jlab. Some learning curve applicable.
- 23643070: Entry Criteria: Ext Pred: / Magnets Installed / Steps: Finalize Rack Dwgs; Install PLC Components; Install and Cable Transducers; Install BELS Interface; Program BTM; HW Checkout
- 23643102: Steps: Clean/Assemble Parts; Assemble Stopper/Diffusers (3); Test Stoppers in Lab; Fab Switch Panels (3); Final Cleaning and Assembly; Update EPICS Controls; Electrical/Pneumatic Testing / BOE NOTES: Materials Prices volatile

| ID | WBS | Activity | Type | Duration | Start | Finish | Predecessors | Total float | Free float | Calendar | Resources | Cost | Original Activity ID Rebaseline | RESP - Responsibility | STRT%COMP for CM EVM | FNSH%COMP for CM EVM | EVMS Reporting Codes | CAM RESPONSIBLE | Activities with Steps | CR 12-037 | BOE Labor | CR 13-015 | Post Rebaseline | CR 14-001 | BOE Procurement | CR 12-018 | CR 12-045 | CR 12-053 | Milestone Level | CR 10-031 | CR 10-059 | CR 11-044 | CR 08-058 | CR 10-070 | CR 11-026 | CR 12-029 | CR 12-035 | CR 12-026 | CR 13-014 | CR 08-016 | CR 09-012 | ReBaseline Actuals Adjustment | BOE Expenses |
| --- | --- | --- | --- | --- | --- | --- | --- | --- | --- | --- | --- | --- | --- | --- | --- | --- | --- | --- | --- | --- | --- | --- | --- | --- | --- | --- | --- | --- | --- | --- | --- | --- | --- | --- | --- | --- | --- | --- | --- | --- | --- | --- | --- |
| 23643115 |  | Test/QA PSS Beam Current Monitor Compnts |  | 30d | 2013-11-01 | 2013-12-16 | 9-140M FS+23d | 72d | 0d | 8/5 M-F w/JLAB Holidays ReBaseline | ELEC ENG [12.94 h]; ELEC TECH [6.47 h] | 1,276.13 | 23643115 | MAHONEY K | 1 | 1 | S | MIKE S | ST | 12-037F | PE | 13-015 | PR | 14-001 |  |  |  |  |  |  |  |  |  |  |  |  |  |  |  |  |  |  |  |
| 23643150 |  | Proc Equipment for H-A, B, C Upgrades (PSS) |  | 74d | 2013-11-04 | 2014-02-28 | 9-140M FS+24d | 18d | 0d | 8/5 M-F w/JLAB Holidays ReBaseline | PROCUREMENT<$50K 60 | 7,473.37 | 23643150 | MAHONEY K | 1 | 1 | S | MIKE S | ST | 12-037F |  | 13-015 | PR | 14-001 | PE |  |  |  |  |  |  |  |  |  |  |  |  |  |  |  |  |  |  |
| 23643205 |  | Install Public Address Sys (PSS) |  | 29d | 2013-11-04 | 2013-12-16 | 9-140M FS+24d | 76d | 11d | 8/5 M-F w/JLAB Holidays ReBaseline | ELEC ENG [16 h]; ELEC TECH [64 h] | 4,209.44 | 23643205 | MAHONEY K | 1 | 1 | S | MIKE S | ST | 12-037 | PE | 13-015 | PR | 14-001 |  | 12-018F |  |  |  |  |  |  |  |  |  |  |  |  |  |  |  |  |  |
| 23643280 |  | EPICS Interface Development |  | 54d | 2013-11-04 | 2014-01-31 | 9-140M FS+24d | 51d | 30d | 8/5 M-F w/JLAB Holidays ReBaseline | ELEC ENG [40 h]; COMP SCIENT [120 h] | 11,389.6 | 23643280 | MAHONEY K | 1 | 1 | S | MIKE S | ST | 12-037 | PE | 13-015 | PR | 14-001 |  | 12-018F | 12-045 | 12-053 |  |  |  |  |  |  |  |  |  |  |  |  |  |  |  |
| 23643070a |  | Install Beam Transport Monitor - EPICS Interface (PSS) |  | 22d | 2013-12-02 | 2014-01-10 | 23643065 FS-12d, 23643070 FS-15d | 65d | 0d | 8/5 M-F w/JLAB Holidays ReBaseline | COMP SCIENT [120 h]; ELEC ENG [40 h] | 11,389.6 | 23643070a | MAHONEY K | 1 | 1 | S | MIKE S | ST | 12-037 | PE | 13-015 | PR | 14-001 |  |  |  |  |  |  |  |  |  |  |  |  |  |  |  |  |  |  |  |
| 23643160 |  | Create & Simulate PSS Logic Programs |  | 24d | 2013-12-03 | 2014-01-15 | 9-140M FS+43d | 62d | 0d | 8/5 M-F w/JLAB Holidays ReBaseline | ELEC ENG [120 h] | 9,015.6 | 23643160 | MAHONEY K | 1 | 1 | S | MIKE S | ST | 12-037F | PE | 13-015 | PR | 14-001 |  |  |  |  |  |  |  |  |  |  |  |  |  |  |  |  |  |  |  |
| 23643155 |  | Install & Test H-A, B, C Upgrades (PSS) |  | 54d | 2013-12-04 | 2014-02-28 | 23643150 FS-54d | 18d | 0d | 8/5 M-F w/JLAB Holidays ReBaseline | ELEC ENG [40 h]; ELEC TECH [120 h] | 8,644 | 23643155 | MAHONEY K | 1 | 1 | S | MIKE S | ST | 12-037 | PE | 13-015 | PR | 14-001 |  |  |  |  |  |  |  |  |  |  |  |  |  |  |  |  |  |  |  |
| 23643180M |  | Tagger Bldng PSS Systems Comp | milestone | 0d | 2013-12-16 | 2013-12-16 | 23643145b, 23643145a, 23643145, 23643145ba | 76d | 11d | 8/5 M-F w/JLAB Holidays ReBaseline |  |  | 23643180M | MAHONEY K | 1 | 1 | M | MIKE S |  | 12-037 |  | 13-015 | PR |  |  | 12-018F |  |  | 6 |  |  |  |  |  |  |  |  |  |  |  |  |  |  |
| 23643165 |  | Install & Test PSS Logic Programs |  | 10d | 2014-01-02 | 2014-01-15 | 23643160 FS-10d | 62d | 0d | 8/5 M-F w/JLAB Holidays ReBaseline | ELEC TECH [32.97 h]; ELEC ENG [131.89 h] | 11,458.16 | 23643165 | MAHONEY K | 1 | 1 | S | MIKE S | ST | 12-037F | PE | 13-015 | PR | 14-001 |  |  |  |  |  | 10-031 | 10-059 | 11-044 |  |  |  |  |  |  |  |  |  |  |  |
| 23643185M |  | H-D PSS Systems Comp | milestone | 0d | 2014-01-10 | 2014-01-10 | 23643205, 23643145ba, 23643070a, 23643070, 23643180M, 23643145, 23643120, 23643145b, 23643145a | 65d | 44d | 8/5 M-F w/JLAB Holidays ReBaseline |  |  | 23643185M | MAHONEY K | 1 | 1 | M | MIKE S |  | 12-037 |  | 13-015 | PR |  |  | 12-018F |  |  | 6 |  |  |  |  |  |  |  |  |  |  |  |  |  |  |
| 23643175M |  | Halls A, B, C PSS Systems Comp | milestone | 0d | 2014-02-28 | 2014-02-28 | 23643155 | 18d | 0d | 8/5 M-F w/JLAB Holidays ReBaseline |  |  | 23643175M | MAHONEY K | 1 | 1 | M | MIKE S |  | 12-037 |  | 13-015 | PR |  |  |  |  |  | 6 |  |  |  |  |  |  |  |  |  |  |  |  |  |  |
|  | 5 | **1.3.6.5 DUMPS (HALL D & INSERTABLE)** |  |  | 2009-01-02 | 2014-01-17 |  |  |  |  |  |  |  |  |  |  |  |  |  |  |  |  |  |  |  |  |  |  |  |  |  |  |  |  |  |  |  |  |  |  |  |  |  |
| 1365909LOE |  | FY09 Mngmnt Effort for Dump |  | 189d | 2009-01-02 | 2009-09-30 | 1365909LOEX | 20d | 0d |  | SR STAFF [3.05 h] | 313.66 |  | GARZA O | 1 | 1 |  | MIKE S |  |  |  |  |  |  |  |  |  |  |  |  |  |  | 08-058 |  |  |  |  |  |  |  |  |  |  |
| 1365910LOE |  | FY10 Mngmnt Effort for Dump |  | 248d | 2009-10-01 | 2010-09-30 | 1365909LOE | 20d | 0d |  | SR STAFF [4 h] | 424.48 |  | GARZA O | 1 | 1 |  | MIKE S |  |  |  |  |  |  |  |  |  |  |  |  |  |  |  |  |  |  |  |  |  |  |  |  |  |
| 1365911LOE |  | FY11 Mngmnt Effort for Dump |  | 248d | 2010-10-01 | 2011-09-30 | 1365910LOE | 20d | 0d |  | SR STAFF [24 h] | 2,628.24 |  | GARZA O | 1 | 1 |  | MIKE S |  |  |  |  |  |  |  |  |  |  |  |  |  |  |  |  |  |  |  |  |  |  |  |  |  |
| 1365014 |  | HD Dump Sys Prcrmnts |  | 40d | 2011-10-03 | 2011-11-29 | 12165030, 9-120M, 12165035 | 310d | 0d |  | ELEC TECH [40 h]; PROCUREMENT<$50K 60; ELEC ENG [80 h] | 24,960.09 |  | GARZA O | 1 | 1 |  | MIKE S |  |  |  |  |  |  |  | 12-018F |  |  |  |  |  |  |  | 10-070 | 11-026 | 12-029F | 12-035F |  |  |  |  |  |  |
| 1365912LOE |  | FY12 Mngmnt Effort for Dump |  | 247d | 2011-10-03 | 2012-09-28 | 1365911LOE | 20d | 0d |  | SR STAFF [24 h] | 2,712 |  | GARZA O | 1 | 1 |  | MIKE S |  |  |  |  |  |  |  |  |  |  |  |  |  |  |  |  |  |  |  |  |  |  |  |  |  |
| 1365015 |  | HD Dump Sys Fab & Assy |  | 80d | 2011-11-30 | 2012-03-30 | 1365014 | 310d | 127d |  | PROCUREMENT<$50K 60; ELEC DES [40 h]; SUPPLIES & MATERIALS; ELEC ENG [80 h]; ELEC TECH [400 h] | 37,567.17 |  | GARZA O | 1 | 1 |  | MIKE S |  |  |  |  |  |  |  | 12-018F |  |  |  |  |  |  |  | 10-070 | 11-026 | 12-029F | 12-035F |  |  |  |  |  |  |
| 1365040 |  | Insertable Dump Sys Prcrmnts |  | 40d | 2012-01-05 | 2012-03-02 | 9-120M FS+60d, 12165035, 12165030 | 320d | 147d |  | PROCUREMENT<$50K 60; ELEC TECH [40 h] | 13,465.26 |  | GARZA O | 1 | 1 |  | MIKE S |  |  |  |  |  |  |  | 12-018F |  |  |  |  |  |  |  | 10-070 | 11-026 | 12-029F | 12-035F | 12-026F |  |  |  |  |  |
| 1365020 |  | HD Dump Component Testing |  | 120d | 2012-10-01 | 2013-03-29 | 1365015, 9-130M | 183d | 0d |  | ELEC ENG [320 h]; ELEC TECH [80 h]; COMP SCIENT [160 h] | 37,776 |  | GARZA O | 1 | 1 |  | MIKE S |  |  |  |  |  |  |  | 12-018F |  |  |  |  |  |  |  | 10-070 | 11-026 | 12-029F | 12-035F | 12-026 |  |  |  |  |  |
| 1365045 |  | Insertable Dump Sys Fab & Assy |  | 60d | 2012-10-01 | 2013-01-02 | 9-130M, 1365040 | 173d | 0d |  | ELEC TECH [240 h]; PROCUREMENT<$50K 60; SUPPLIES & MATERIALS; ELEC DES [80 h] | 29,780.31 |  | GARZA O | 1 | 1 |  | MIKE S |  |  |  |  |  |  |  | 12-018F |  |  |  |  |  |  |  | 10-070 | 11-026 | 12-029F | 12-035F | 12-026 |  |  |  |  |  |
| 1365913LOE |  | FY13 Mngmnt Effort for Dump |  | 228d | 2012-10-01 | 2013-08-30 | 1365912LOE | 20d |  |  | SR STAFF [22.06 h] | 2,572.2 |  | GARZA O | 1 | 1 |  | MIKE S |  |  |  |  |  |  |  |  |  |  |  |  |  |  |  |  |  |  |  |  | 13-014 |  |  |  |  |
| 1365050 |  | Insertable Dump Component Testing |  | 35d | 2013-01-03 | 2013-02-22 | 1365045 | 173d | 0d |  | ELEC ENG [40 h]; ELEC TECH [80 h] | 6,555.6 |  | GARZA O | 1 | 1 |  | MIKE S |  |  |  |  |  |  |  | 12-018F |  |  |  |  |  |  |  | 10-070 | 11-026 | 12-029F | 12-035F | 12-026 |  |  |  |  |  |
| 1365060 |  | Insertable Dump Software Implementn & Cmmssng |  | 120d | 2013-02-08 | 2013-07-30 | 1363035, 1365055 FS-80d | 173d | 0d |  | ELEC TECH [80 h]; ELEC ENG [200 h]; COMP SCIENT [160 h] | 29,038.8 |  | GARZA O | 1 | 1 |  | MIKE S |  |  |  |  |  |  |  | 12-018F |  |  |  |  |  |  |  | 10-070 | 11-026 | 12-029F | 12-035F | 12-026 |  |  |  |  |  |
| 1365055 |  | Insertable Dump Sys Implementn |  | 70d | 2013-02-25 | 2013-06-03 | 1365050, 1362025 | 173d | 0d |  | PLABOR; ELEC TECH [240 h]; ELEC DES [40 h]; PROCUREMENT<$50K 60 | 20,399.64 |  | GARZA O | 1 | 1 |  | MIKE S |  |  |  |  |  |  |  | 12-018F |  |  |  |  |  |  |  | 10-070 | 11-026 | 12-029F | 12-035F | 12-026 |  | 08-016 | 09-012 |  |  |
| 1365025 |  | HD Dump Sys Implementn |  | 60d | 2013-04-01 | 2013-06-24 | 16331030, 1365020, 16331032 | 183d | 0d |  | PLABOR; ELEC TECH [160 h]; ELEC DES [40 h]; PROCUREMENT<$50K 60 | 13,134.45 |  | GARZA O | 1 | 1 |  | MIKE S |  |  |  |  |  |  |  | 12-018F |  |  |  |  |  |  |  | 10-070 | 11-026 | 12-029F | 12-035F | 12-026 |  | 08-016 | 09-012 |  |  |
| 1365030 |  | HD Dump Software Implementn & Cmmssng |  | 55d | 2013-04-29 | 2013-07-16 | 1365025 FS-40d | 183d | 0d |  | ELEC TECH [80 h]; COMP SCIENT [320 h]; ELEC ENG [120 h] | 34,047.6 |  | GARZA O | 1 | 1 |  | MIKE S |  |  |  |  |  |  |  | 12-018F |  |  |  |  |  |  |  | 10-070 | 11-026 | 12-029F | 12-035F | 12-026 |  |  |  |  |  |
| 1365035M |  | HD Dump Comp | milestone | 0d | 2013-07-16 | 2013-07-16 | 1365030 | 183d | 138d |  |  |  |  | GARZA O | 1 | 1 |  | MIKE S |  |  |  |  |  |  |  | 12-018F |  |  | 6 |  |  |  |  | 10-070 | 11-026 | 12-029F | 12-035F | 12-026 |  |  |  |  |  |
| 1365065M |  | Insertable Dump Comp | milestone | 0d | 2013-07-30 | 2013-07-30 | 1365060 | 173d | 128d |  |  |  |  | GARZA O | 1 | 1 |  | MIKE S |  |  |  |  |  |  |  | 12-018F |  |  | 6 |  |  |  |  | 10-070 | 11-026 | 12-029F | 12-035F | 12-026 |  |  |  |  |  |
| 1365950 |  | Re-Baseline Actuals Adjustment |  | 1d | 2013-08-30 | 2013-08-30 | 9-130M FS+227d | 20d |  |  | PROCUREMENT>$50K 69 NO ESCALATION | -109,636.21 |  | GARZA O | 1 | 1 |  | MIKE S |  |  |  |  |  |  |  |  |  |  |  |  |  |  |  |  |  |  |  |  | 13-014 |  |  | ADJ |  |
| 2365913LOE |  | FY13 Mngmnt Effort for Dump |  | 20d | 2013-09-03 | 2013-09-30 | 9-130M FS+228d | 89d |  | 8/5 M-F w/JLAB Holidays ReBaseline | SCIENTIST [2.68 h] | 195.26 | 2365913LOE | GARZA O | 1 | 1 | E | MIKE S |  |  | PE | 13-015 | PR |  |  |  |  |  |  |  |  |  |  |  |  |  |  |  |  |  |  |  |  |
| 2365014 |  | HD Dump Sys Prcrmnts |  | 19d | 2013-10-01 | 2013-10-25 | 9-140M | 60d | 0d | 8/5 M-F w/JLAB Holidays ReBaseline | PROCUREMENT<$50K 60; ELEC TECH [32 h] | 7,695.08 | 2365014 | GARZA O | 1 | 1 |  | MIKE S |  |  | PE | 13-015 | PR | 14-001 | EV | 12-018F |  |  |  |  |  |  |  | 10-070 | 11-026 | 12-029F | 12-035F |  |  |  |  |  |  |
| 2365015 |  | HD Dump Sys Fab & Assy |  | 19d | 2013-10-01 | 2013-10-25 | 2365014 FS-19d | 60d | 0d | 8/5 M-F w/JLAB Holidays ReBaseline | PROCUREMENT<$50K 60; SUPPLIES & MATERIALS; ELEC TECH [160 h] | 10,536.73 | 2365015 | GARZA O | 1 | 1 |  | MIKE S |  |  | PE | 13-015 | PR | 14-001 | EV | 12-018F |  |  |  |  |  |  |  | 10-070 | 11-026 | 12-029F | 12-035F |  |  |  |  |  | PE |
| 2365020 |  | HD Dump Component Testing |  | 19d | 2013-10-01 | 2013-10-25 | 2365015 FS-19d | 60d | 0d | 8/5 M-F w/JLAB Holidays ReBaseline | ELEC TECH [84 h]; COMP SCIENT [28 h] | 5,903.52 | 2365020 | GARZA O | 1 | 1 |  | MIKE S |  |  | PE | 13-015 | PR | 14-001 |  | 12-018F |  |  |  |  |  |  |  | 10-070 | 11-026 | 12-029F | 12-035F | 12-026 |  |  |  |  |  |
| 2365025 |  | HD Dump Sys Implementn |  | 54d | 2013-10-01 | 2013-12-17 | 23458045a FS-47d, 23458045 FS-47d, 2365020 FS-19d | 60d | 0d | 8/5 M-F w/JLAB Holidays ReBaseline | PLABOR; ELEC TECH [112 h]; ELEC DES [28 h]; PROCUREMENT<$50K 60 | 11,748.95 | 2365025 | GARZA O | 1 | 1 |  | MIKE S |  |  | PE | 13-015 | PR | 14-001 | EV | 12-018F |  |  |  |  |  |  |  | 10-070 | 11-026 | 12-029F | 12-035F | 12-026 |  | 08-016 | 09-012 |  | PE |
| 2365045 |  | Insertable Dump Sys Fab & Assy |  | 19d | 2013-10-01 | 2013-10-25 | 9-140M | 11d | 0d | 8/5 M-F w/JLAB Holidays ReBaseline | ELEC TECH [48 h]; PROCUREMENT<$50K 60; SUPPLIES & MATERIALS; ELEC DES [16 h] | 4,288.47 | 2365045 | GARZA O | 1 | 1 |  | MIKE S |  |  | PE | 13-015 | PR | 14-001 | EV | 12-018F |  |  |  |  |  |  |  | 10-070 | 11-026 | 12-029F | 12-035F | 12-026 |  |  |  |  | PE |
| 2365050 |  | Insertable Dump Component Testing |  | 19d | 2013-10-01 | 2013-10-25 | 2365045 FS-19d | 11d | 0d | 8/5 M-F w/JLAB Holidays ReBaseline | ELEC TECH [32 h] | 1,503.68 | 2365050 | GARZA O | 1 | 1 |  | MIKE S |  |  | PE | 13-015 | PR | 14-001 |  | 12-018F |  |  |  |  |  |  |  | 10-070 | 11-026 | 12-029F | 12-035F | 12-026 |  |  |  |  |  |
| 2365055 |  | Insertable Dump Sys Implementn |  | 19d | 2013-10-01 | 2013-10-25 | 2365050 FS-19d | 11d | 0d | 8/5 M-F w/JLAB Holidays ReBaseline | ELEC TECH [24 h] | 1,127.76 | 2365055 | GARZA O | 1 | 1 |  | MIKE S |  |  | PE | 13-015 | PR | 14-001 | EV | 12-018F |  |  |  |  |  |  |  | 10-070 | 11-026 | 12-029F | 12-035F | 12-026 |  | 08-016 | 09-012 |  | PE |
| 2365060 |  | Insertable Dump Software Implementn & Cmmssng |  | 19d | 2013-10-01 | 2013-10-25 | 23458040 FS-30d, 2365055 FS-19d, 23458040a FS-30d | 11d | 0d | 8/5 M-F w/JLAB Holidays ReBaseline | ELEC TECH; ELEC ENG; COMP SCIENT |  | 2365060 | GARZA O | 1 | 1 |  | MIKE S |  |  | PE | 13-015 | PR |  |  | 12-018F |  |  |  |  |  |  |  | 10-070 | 11-026 | 12-029F | 12-035F | 12-026 |  |  |  |  |  |
| 2365030 |  | HD Dump Software Implementn & Cmmssng |  | 55d | 2013-10-21 | 2014-01-17 | 2365025 FS-40d | 60d | 0d | 8/5 M-F w/JLAB Holidays ReBaseline | COMP SCIENT [80 h]; ELEC ENG [40 h] | 8,594.8 | 2365030 | GARZA O | 1 | 1 |  | MIKE S |  |  | PE | 13-015 | PR | 14-001 |  | 12-018F |  |  |  |  |  |  |  | 10-070 | 11-026 | 12-029F | 12-035F | 12-026 |  |  |  |  |  |
| 2365065M |  | Insertable Dump Comp | milestone | 0d | 2013-10-25 | 2013-10-25 | 2365060 | 11d | 0d | 8/5 M-F w/JLAB Holidays ReBaseline |  |  | 2365065M | GARZA O | 1 | 1 |  | MIKE S |  |  |  | 13-015 | PR |  |  | 12-018F |  |  | 6 |  |  |  |  | 10-070 | 11-026 | 12-029F | 12-035F | 12-026 |  |  |  |  |  |
| 2365035M |  | HD Dump Comp | milestone | 0d | 2014-01-17 | 2014-01-17 | 2365030 | 60d | 14d | 8/5 M-F w/JLAB Holidays ReBaseline |  |  | 2365035M | GARZA O | 1 | 1 | M | MIKE S |  |  |  | 13-015 | PR |  |  | 12-018F |  |  | 6 |  |  |  |  | 10-070 | 11-026 | 12-029F | 12-035F | 12-026 |  |  |  |  |  |

Notes:
- 23643115: Steps: Test/Align Electronic Cards (Test Fixture) / BOE NOTES: Adder due to personnel that engineered BCM is no longer at Jlab. Some learning curve applicable.
- 23643150: Steps: Hall A PSS Equip (ESTop, R/S, Message Disp.); Hall B PSS Equip (ESTop, R/S, Message Disp.); Hall C PSS Equip (ESTop, R/S, Message Disp.); Counting House PSS Equip / BOE NOTES: Based on extrapolation of similar work in support of 6GeV experimental program.
- 23643205: Entry Criteria: Ext Pred: BOD Tagger Bldg, Hall / D, Tunnel Ext / Steps: Install Hall D PA Equipment; Install Tagger PA Equipment; Compelte Wire and Cable Interconnects; Tie-in to MCC PA System / BOE NOTES: Judgment based on knowledge and experience with PA systems as well as informal consultation with vendor experts.
- 23643280: Steps: Tag DB - EPICS Records; Install SW for PSS; Test / BOE NOTES: Judgment based on experience of other labs, and internal experience developing interface for ODH systems.
- 23643070a: Entry Criteria: Ext Pred: / Magnets Installed / Steps: Finalize Specifications; Deliver Tag Database; Create Application; Bench Test; Field Test
- 23643160: Steps: Program Development; Bench Test; Acceptance Test / BOE NOTES: Based on experience designing and implementing systems for SLAC. JLab configuration is different enough to warrant EJ vs. PE.
- 23643155: Steps: Hall A PSS Upgrade Support; Hall B PSS Upgrade Support; Hall C PSS Upgrade Support; As-Built Documentation / BOE NOTES: Emerging Requirements for Endstation PSS/MPS may delay until FY14-FY15
- 23643165: Steps: Verify Field I/O; Load Program/Clear Errors; Test Standard Functions; Test Fail-Safe Functions; Test Integrated System
- 1365060: Entry Criteria: Ext Pred: Beam
- 1365055: Entry Criteria: Ext Pred: IOC, network, beamine / installed, vacuum
- 1365025: Entry Criteria: Ext Pred: Beamline installed, / vacuum
- 1365030: Entry Criteria: Ext Pred: Beam
- 2365025: Entry Criteria: Ext Pred: Beamline installed, / vacuum
- 2365055: Entry Criteria: Ext Pred: IOC, network, beamine / installed, vacuum
- 2365060: Entry Criteria: Ext Pred: Beam
- 2365030: Entry Criteria: Ext Pred: Beam

| ID | WBS | Activity | Type | Duration | Start | Finish | Predecessors | Total float | Free float | Calendar | Resources | Cost | RESP - Responsibility | STRT%COMP for CM EVM | FNSH%COMP for CM EVM | CAM RESPONSIBLE | CR 08-058 | CR 10-031 | CR 10-070 | CR 12-001 | CR 10-064 | CR 10-066 | Milestone Level | CR 11-026 | CR 12-018 | CR 12-029 | CR 12-035 | CR 12-053 | CR 13-003 | CR 13-014 | ReBaseline Actuals Adjustment | Original Activity ID Rebaseline | BOE Labor | CR 13-015 | Post Rebaseline | EVMS Reporting Codes |
| --- | --- | --- | --- | --- | --- | --- | --- | --- | --- | --- | --- | --- | --- | --- | --- | --- | --- | --- | --- | --- | --- | --- | --- | --- | --- | --- | --- | --- | --- | --- | --- | --- | --- | --- | --- | --- |
|  | 6 | **1.3.6.6 VACUUM CONTROLS** |  |  | 2009-01-02 | 2013-09-27 |  |  |  |  |  |  |  |  |  |  |  |  |  |  |  |  |  |  |  |  |  |  |  |  |  |  |  |  |  |  |
| 1366909LOE |  | FY09 Mngmnt Effort for SRFand ARC Vac Controls |  | 189d | 2009-01-02 | 2009-09-30 | 1366909LOEX | 20d | 0d |  | SR STAFF [3.05 h] | 313.66 | GARZA O | 1 | 1 | MIKE S | 08-058 |  |  |  |  |  |  |  |  |  |  |  |  |  |  |  |  |  |  |  |
| 1366910LOE |  | FY10 Mngmnt Effort for SRFand ARC Vac Controls |  | 248d | 2009-10-01 | 2010-09-30 | 1366909LOE | 20d | 0d |  | SR STAFF [4 h] | 424.48 | GARZA O | 1 | 1 | MIKE S |  |  |  |  |  |  |  |  |  |  |  |  |  |  |  |  |  |  |  |  |
| 1366014 |  | SRF Vac Controls Sys Prcrmnts |  | 40d | 2010-05-03 | 2010-06-28 | 12166035, 9-100M FS+142d | 504d | 66d |  | ELEC ENG [160 h]; ELEC TECH [160 h]; PROCUREMENT<$50K 60 | 242,486.18 | GARZA O | 1 | 1 | MIKE S |  | 10-031 | 10-070 |  |  |  |  |  |  |  |  |  |  |  |  |  |  |  |  |  |
| 1366015 |  | SRF Vac Controls Hardware Fab/Assy/Configuration |  | 160d | 2010-10-01 | 2011-05-26 | 1366014, 9-110M | 438d | 0d |  | ELEC ENG [200 h]; ELEC TECH [400 h]; SUPPLIES & MATERIALS; TRAVEL; PROCUREMENT<$50K 60; ELEC DES [80 h] | 119,567.67 | GARZA O | 1 | 1 | MIKE S |  | 10-031 | 10-070 |  |  |  |  |  |  |  |  |  |  |  |  |  |  |  |  |  |
| 1366911LOE |  | FY11 Mngmnt Effort for SRFand ARC Vac Controls |  | 248d | 2010-10-01 | 2011-09-30 | 1366910LOE | 20d | 0d |  | SR STAFF [36 h] | 3,942.36 | GARZA O | 1 | 1 | MIKE S |  |  |  |  |  |  |  |  |  |  |  |  |  |  |  |  |  |  |  |  |
| 1366020 |  | SRF Vac Controls Sys Installtn Labor FY11 |  | 88d | 2011-05-27 | 2011-09-30 | 1366015, 1362025 FS-115d | 438d | 0d |  | ELEC DES [54.15 h]; ELEC TECH [433.23 h] | 21,179.89 | GARZA O | 1 | 1 | MIKE S |  | 10-031 | 10-070 | 12-001 |  |  |  |  |  |  |  |  |  |  |  |  |  |  |  |  |
| 1366020b |  | SRF Vac Controls Sys Installtn Labor Procurement |  | 130d | 2011-05-27 | 2011-12-01 | 1362025 FS-115d, 1366015 | 438d | 0d |  | PROCUREMENT<$50K 60 NO ESCALATION FY12 | 28,345.91 | GARZA O | 1 | 1 | MIKE S |  | 10-031 | 10-070 | 12-001 |  |  |  |  |  |  |  |  |  |  |  |  |  |  |  |  |
| 1366025 |  | SRF Vac Controls Software Implementn & Sys Testing FY11 |  | 83d | 2011-06-06 | 2011-09-30 | 1366020a FS-125d, 1366020b FS-125d | 438d | 0d |  | COMP SCIENT [221.33 h]; ELEC ENG [66.4 h]; ELEC TECH [66.4 h] | 21,454.73 | GARZA O | 1 | 1 | MIKE S |  | 10-031 | 10-070 | 12-001 | 10-064 | 10-066 |  |  |  |  |  |  |  |  |  |  |  |  |  |  |
| 1366020a |  | SRF Vac Controls Sys Installtn Labor FY12 |  | 42d | 2011-10-03 | 2011-12-01 | 1366020 | 438d | 0d |  | ELEC TECH [206.77 h]; ELEC DES [25.85 h] | 10,430.44 | GARZA O | 1 | 1 | MIKE S |  | 10-031 | 10-070 | 12-001 |  |  |  |  |  |  |  |  |  |  |  |  |  |  |  |  |
| 1366025a |  | SRF Vac Controls Software Implementn & Sys Testing FY12 |  | 67d | 2011-10-03 | 2012-01-13 | 1366025 | 438d | 0d |  | ELEC TECH [53.6 h]; COMP SCIENT [178.67 h]; ELEC ENG [53.6 h] | 17,871.72 | GARZA O | 1 | 1 | MIKE S |  | 10-031 | 10-070 | 12-001 | 10-064 | 10-066 |  |  |  |  |  |  |  |  |  |  |  |  |  |  |
| 1366912LOE |  | FY12 Mngmnt Effort for SRFand ARC Vac Controls |  | 247d | 2011-10-03 | 2012-09-28 | 1366911LOE | 20d | 0d |  | SR STAFF [36 h] | 4,068 | GARZA O | 1 | 1 | MIKE S |  |  |  |  |  |  |  |  |  |  |  |  |  |  |  |  |  |  |  |  |
| 1366030M |  | SRF Vacuum Controls Sys Comp | milestone | 0d | 2012-01-13 | 2012-01-13 | 1366025a | 438d |  |  |  |  | GARZA O | 1 | 1 | MIKE S |  | 10-031 | 10-070 |  | 10-064 | 10-066 | 6 |  |  |  |  |  |  |  |  |  |  |  |  |  |
| 1366035 |  | ARC Vac Controls Sys Prcrmnts |  | 40d | 2012-02-03 | 2012-03-30 | 12166035, 9-120M FS+80d | 355d | 0d |  | ELEC ENG [40 h]; ELEC TECH [120 h]; PROCUREMENT<$50K 60 | 81,828.37 | GARZA O | 1 | 1 | MIKE S |  |  | 10-070 |  |  |  |  | 11-026 | 12-018F | 12-029F | 12-035F |  |  |  |  |  |  |  |  |  |
| 1366040 |  | ARC Vac Controls Hardware Fab/Assy/Configuration |  | 90d | 2012-04-02 | 2012-08-07 | 1366035 | 355d | 0d |  | SUPPLIES & MATERIALS; TRAVEL; PROCUREMENT<$50K 60; ELEC DES [40 h]; ELEC TECH [320 h] | 39,003.91 | GARZA O | 1 | 1 | MIKE S |  |  | 10-070 |  |  |  |  | 11-026 | 12-018F | 12-029F | 12-035F |  |  |  |  |  |  |  |  |  |
| 1366050 |  | ARC Vac Controls Software Implementn & Sys Testing FY12 |  | 47d | 2012-07-25 | 2012-09-28 | 1366045b FS-55d, 1366047 FS-55d, 1362025, 1366045a FS-55d | 355d | 0d |  | COMP SCIENT [107.43 h]; ELEC TECH [53.71 h] | 9,419.78 | GARZA O | 1 | 1 | MIKE S |  |  | 10-070 |  |  |  |  | 11-026 | 12-018F | 12-029F | 12-035F | 12-053 |  |  |  |  |  |  |  |  |
| 1366045 |  | ARC Vac Controls Sys Installtn FY12 |  | 37d | 2012-08-08 | 2012-09-28 | 2-02M, 1366040 | 355d | 0d |  | PLABOR; ELEC TECH [164.44 h]; ELEC DES [32.89 h] | 11,068.1 | GARZA O | 1 | 1 | MIKE S |  |  | 10-070 |  |  |  |  | 11-026 | 12-018F | 12-029F | 12-035F | 12-053 |  |  |  |  |  |  |  |  |
| 1366045b |  | ARC Vac Controls Sys Installtn Procurement |  | 45d | 2012-08-08 | 2012-10-10 | 1366040, 2-02M | 355d | 0d |  | PROCUREMENT<$50K 60 NO ESCALATION FY13 | 17,550.09 | GARZA O | 1 | 1 | MIKE S |  |  | 10-070 |  |  |  |  | 11-026 | 12-018F | 12-029F | 12-035F | 12-053 |  |  |  |  |  |  |  |  |
| 1366045a |  | ARC Vac Controls Sys Installtn FY13 |  | 8d | 2012-10-01 | 2012-10-10 | 1366045 | 355d | 0d |  | PLABOR; ELEC TECH [35.56 h]; ELEC DES [7.11 h] | 2,469.68 | GARZA O | 1 | 1 | MIKE S |  |  | 10-070 |  |  |  |  | 11-026 | 12-018F | 12-029F | 12-035F | 12-053 |  |  |  |  |  |  |  |  |
| 1366047 |  | ARC Vac Controls Sys Installtn Additonal effort per 2012 ETC |  | 8d | 2012-10-01 | 2012-10-10 | 9-130M | 355d | 0d |  | ELEC TECH [480 h]; ELEC ENG [88 h]; PROCUREMENT<$50K 60 | 40,266.48 | GARZA O | 1 | 1 | MIKE S |  |  | 10-070 |  |  |  |  | 11-026 | 12-018F | 12-029F | 12-035F | 12-053 | 13-003 |  |  |  |  |  |  |  |
| 1366050a |  | ARC Vac Controls Software Implementn & Sys Testing FY13 |  | 23d | 2012-10-01 | 2012-10-31 | 1366050 | 355d | 0d |  | COMP SCIENT [52.57 h]; ELEC TECH [26.29 h] | 4,756.76 | GARZA O | 1 | 1 | MIKE S |  |  | 10-070 |  |  |  |  | 11-026 | 12-018F | 12-029F | 12-035F | 12-053 |  |  |  |  |  |  |  |  |
| 1366055M |  | ARC Vacuum Controls Sys Comp | milestone | 0d | 2012-10-31 | 2012-10-31 | 1366050a | 355d | 310d |  |  |  | GARZA O | 1 | 1 | MIKE S |  |  | 10-070 |  |  |  | 6 | 11-026 | 12-018F | 12-029F | 12-035F |  |  |  |  |  |  |  |  |  |
| 1366950 |  | Re-Baseline Actuals Adjustment |  | 1d | 2013-08-30 | 2013-08-30 | 9-130M FS+227d | 20d |  |  | PROCUREMENT>$50K 69 NO ESCALATION | 222,962.04 | GARZA O | 1 | 1 | MIKE S |  |  |  |  |  |  |  |  |  |  |  |  |  | 13-014 | ADJ |  |  |  |  |  |
| 2366050a |  | ARC Vac Controls Software Implementn |  | 19d | 2013-09-03 | 2013-09-27 | 9-130M FS+228d | 130d | 0d | 8/5 M-F w/JLAB Holidays ReBaseline | COMP SCIENT [88 h] | 5,958.48 | GARZA O | 1 | 1 | MIKE S |  |  | 10-070 |  |  |  |  | 11-026 | 12-018F | 12-029F | 12-035F | 12-053 |  |  |  | 2366050a | PE | 13-015 | PR |  |
| 2366051 |  | ARC Vac Controls Hardware Implementation & Testing |  | 19d | 2013-09-03 | 2013-09-27 | 2366050a FS-19d | 130d | 0d | 8/5 M-F w/JLAB Holidays ReBaseline | ELEC TECH [240 h] | 10,929.6 | GARZA O | 1 | 1 | MIKE S |  |  | 10-070 |  |  |  |  | 11-026 | 12-018F | 12-029F | 12-035F | 12-053 |  |  |  | 2366051 | PE | 13-015 | PR |  |
| 2366055M |  | ARC Vacuum Controls Sys Comp | milestone | 0d | 2013-09-27 | 2013-09-27 | 2366050a, 2366051 | 130d | 84d | 8/5 M-F w/JLAB Holidays ReBaseline |  |  | GARZA O | 1 | 1 | MIKE S |  |  | 10-070 |  |  |  | 6 | 11-026 | 12-018F | 12-029F | 12-035F |  |  |  |  | 2366055M |  | 13-015 | PR | M |

Notes:
- 1366020: Entry Criteria: Ext Pred: New CMs installed, / beamliine, IOCs, network
- 1366020b: Entry Criteria: Ext Pred: New CMs installed, / beamliine, IOCs, network
- 1366020a: Entry Criteria: Ext Pred: New CMs installed, / beamliine, IOCs, network
- 1366050: Entry Criteria: Ext Pred: Beamline, IOCs, / network
- 1366050a: Entry Criteria: Ext Pred: Beamline, IOCs, / network
- 2366050a: Entry Criteria: Ext Pred: Beamline, IOCs, / network
- 2366051: Entry Criteria: Ext Pred: Beamline, IOCs, / network

| ID | WBS | Activity | Duration | Start | Finish | Predecessors | Total float | Free float | Calendar | Resources | Cost | RESP - Responsibility | STRT%COMP for CM EVM | FNSH%COMP for CM EVM | CAM RESPONSIBLE | CR 10-070 | CR 10-031 | CR 10-065 | CR 12-035 | CR 12-053 | CR 08-016 | CR 09-012 | CR 13-003 | CR 13-014 | ReBaseline Actuals Adjustment | Original Activity ID Rebaseline | BOE Labor | CR 13-015 | Post Rebaseline | CR 14-001 | BOE Procurement |
| --- | --- | --- | --- | --- | --- | --- | --- | --- | --- | --- | --- | --- | --- | --- | --- | --- | --- | --- | --- | --- | --- | --- | --- | --- | --- | --- | --- | --- | --- | --- | --- |
|  | 7 | **1.3.6.7 MAGNET INSTRUMENTATION** |  | 2011-10-03 | 2014-02-07 |  |  |  |  |  |  |  |  |  |  |  |  |  |  |  |  |  |  |  |  |  |  |  |  |  |  |
| 1367005 |  | Mag Instrmenttn Prcrmnts | 30d | 2011-10-03 | 2011-11-11 | 9-120M, 12167028 | 185d | 0d |  | PROCUREMENT<$50K 60; ELEC TECH [80 h] | 80,750.79 | GARZA O | 1 | 1 | MIKE S | 10-070 |  |  |  |  |  |  |  |  |  |  |  |  |  |  |  |
| 1367010 |  | Mag Instrmenttn Fab & Assy | 100d | 2011-11-14 | 2012-04-13 | 1367005 | 185d | 0d |  | ELEC TECH [360 h]; PROCUREMENT<$50K 60; SUPPLIES & MATERIALS; TRAVEL; ELEC DES [40 h] | 55,347.38 | GARZA O | 1 | 1 | MIKE S | 10-070 |  |  |  |  |  |  |  |  |  |  |  |  |  |  |  |
| 1367015 |  | Mag Instrmenttn Testing | 60d | 2012-04-16 | 2012-07-10 | 9-120M, 1367010 | 185d | 0d |  | ELEC TECH [160 h]; PROCUREMENT<$50K 60; COMP SCIENT [160 h] | 22,240.02 | GARZA O | 1 | 1 | MIKE S | 10-070 |  |  |  |  |  |  |  |  |  |  |  |  |  |  |  |
| 1367025 |  | Mag Instrmenttn Software Implementn & Cmmssng FY12 | 67d | 2012-06-27 | 2012-09-28 | 1367020b FS-130d, 1362025, 1367020a FS-130d | 185d | 0d |  | ELEC TECH [57.43 h]; COMP SCIENT [153.14 h] | 12,583.44 | GARZA O | 1 | 1 | MIKE S | 10-070 | 10-031 | 10-065 | 12-035 | 12-053 |  |  |  |  |  |  |  |  |  |  |  |
| 1367020 |  | Mag Instrmenttn Implementn FY12 | 57d | 2012-07-11 | 2012-09-28 | 1367015, 1362025 FS-115d | 185d | 0d |  | ELEC DES [19 h]; ELEC TECH [247 h]; SUPPLIES & MATERIALS | 13,010.21 | GARZA O | 1 | 1 | MIKE S | 10-070 |  | 10-065 | 12-035 | 12-053 | 08-016 | 09-012 |  |  |  |  |  |  |  |  |  |
| 1367020b |  | Mag Instrmenttn Implementn Procurement | 120d | 2012-07-11 | 2013-01-07 | 1367015, 1362025 FS-115d | 185d | 0d |  | PROCUREMENT<$50K 60 NO ESCALATION FY13 | 14,040.06 | GARZA O | 1 | 1 | MIKE S | 10-070 |  | 10-065 | 12-035 | 12-053 | 08-016 | 09-012 |  |  |  |  |  |  |  |  |  |
| 1367020a |  | Mag Instrmenttn Implementn FY13 | 63d | 2012-10-01 | 2013-01-07 | 1367020 | 185d | 0d |  | ELEC DES [21 h]; ELEC TECH [273 h]; SUPPLIES & MATERIALS | 14,839 | GARZA O | 1 | 1 | MIKE S | 10-070 |  | 10-065 | 12-035 | 12-053 | 08-016 | 09-012 |  |  |  |  |  |  |  |  |  |
| 1367025a |  | Mag Instrmenttn Software Implementn & Cmmssng FY13 | 73d | 2012-10-01 | 2013-01-22 | 1367025 | 185d |  |  | ELEC TECH [62.57 h]; COMP SCIENT [166.86 h] | 14,147.53 | GARZA O | 1 | 1 | MIKE S | 10-070 | 10-031 | 10-065 | 12-035 | 12-053 |  |  |  |  |  |  |  |  |  |  |  |
| 1367030 |  | Magnet Communication New I/O IP design - Labor | 60d | 2013-02-01 | 2013-04-26 | 9-130M FS+80d | 33d | 0d |  | ELEC ENG [172 h]; ELEC TECH [80 h] | 16,166.52 | GARZA O | 1 | 1 | MIKE S | 10-070 | 10-031 | 10-065 | 12-035 | 12-053 |  |  | 13-003 |  |  |  |  |  |  |  |  |
| 1367035 |  | Magnet Communication New I/O IP design - Proc. | 20d | 2013-03-01 | 2013-03-28 | 1367030 FS-41d | 33d | 0d |  | ELEC ENG [28 h]; PROCUREMENT<$50K 60; ELEC TECH [40 h] | 14,860.28 | GARZA O | 1 | 1 | MIKE S | 10-070 | 10-031 | 10-065 | 12-035 | 12-053 |  |  | 13-003 |  |  |  |  |  |  |  |  |
| 1367040 |  | Magnet Communication New I/O IP Fabrication | 40d | 2013-05-01 | 2013-06-26 | 1367035 FS+23d | 33d | 0d |  | PROCUREMENT<$50K 60; ELEC TECH [240 h] | 14,929.6 | GARZA O | 1 | 1 | MIKE S | 10-070 | 10-031 | 10-065 | 12-035 | 12-053 |  |  | 13-003 |  |  |  |  |  |  |  |  |
| 1367045 |  | Magnet Communication New I/O IP Testing | 20d | 2013-06-03 | 2013-06-28 | 1367040 FS-18d | 33d | 0d |  | ELEC TECH [80 h]; ELEC ENG [28 h] | 5,681.88 | GARZA O | 1 | 1 | MIKE S | 10-070 | 10-031 | 10-065 | 12-035 | 12-053 |  |  | 13-003 |  |  |  |  |  |  |  |  |
| 1367050 |  | Magnet Communication New I/O IP Installation | 20d | 2013-07-01 | 2013-07-29 | 1367045 | 33d |  |  | ELEC TECH [80 h]; ELEC ENG [28 h] | 5,681.88 | GARZA O | 1 | 1 | MIKE S | 10-070 | 10-031 | 10-065 | 12-035 | 12-053 |  |  | 13-003 |  |  |  |  |  |  |  |  |
| 1367055 |  | Magnet Communication New I/O IP Software -Labor | 40d | 2013-07-01 | 2013-08-26 | 1367045 | 34d |  |  | ELEC ENG [116 h] | 8,445.96 | GARZA O | 1 | 1 | MIKE S | 10-070 | 10-031 | 10-065 | 12-035 | 12-053 |  |  | 13-003 |  |  |  |  |  |  |  |  |
| 1367060 |  | Re-Baseline Actuals Adjustment | 1d | 2013-08-30 | 2013-08-30 | 9-130M FS+227d | 20d |  |  | PROCUREMENT>$50K 69 NO ESCALATION | -99,867.79 | GARZA O | 1 | 1 | MIKE S |  |  |  |  |  |  |  |  | 13-014 | ADJ |  |  |  |  |  |  |
| 2367025a |  | Mag Instrmenttn Software Implementn & Cmmssng FY13 | 20d | 2013-09-03 | 2013-09-30 | 9-130M FS+228d, 23221024ba FS-198d | 46d | 0d | 8/5 M-F w/JLAB Holidays ReBaseline | ELEC TECH [9.98 h]; COMP SCIENT [26.63 h] | 2,257.51 | GARZA O | 1 | 1 | MIKE S | 10-070 | 10-031 | 10-065 | 12-035 | 12-053 |  |  |  |  |  | 2367025a | PE | 13-015 | PR |  |  |
| 2367030 |  | Magnet Communication New I/O IP design - Labor FY13 | 20d | 2013-09-03 | 2013-09-30 | 9-130M FS+228d | 14d | 0d | 8/5 M-F w/JLAB Holidays ReBaseline | ELEC ENG [4.52 h]; ELEC TECH [2.1 h] | 424.69 | GARZA O | 1 | 1 | MIKE S | 10-070 | 10-031 | 10-065 | 12-035 | 12-053 |  |  | 13-003 |  |  | 2367030 | PE | 13-015 | PR |  |  |
| 2367025aa |  | Mag Instrmenttn Software Implementn & Cmmssng FY14 | 83d | 2013-10-01 | 2014-02-07 | 23221024ba FS-198d, 2367025a, 9-130M FS+228d | 46d | 0d | 8/5 M-F w/JLAB Holidays ReBaseline | ELEC TECH [41.44 h]; COMP SCIENT [110.5 h] | 9,667.97 | GARZA O | 1 | 1 | MIKE S | 10-070 | 10-031 | 10-065 | 12-035 | 12-053 |  |  |  |  |  | 2367025a | PE | 13-015 | PR | 14-001 |  |
| 2367030a |  | Magnet Communication New I/O IP design - Labor FY14 | 32d | 2013-10-01 | 2013-11-13 | 2367030, 9-130M FS+228d | 14d | 0d | 8/5 M-F w/JLAB Holidays ReBaseline | ELEC ENG [7.23 h]; ELEC TECH [3.37 h] | 701.67 | GARZA O | 1 | 1 | MIKE S | 10-070 | 10-031 | 10-065 | 12-035 | 12-053 |  |  | 13-003 |  |  | 2367030 | PE | 13-015 | PR | 14-001 |  |
| 2367050 |  | Magnet Communication New I/O IP Installation | 30d | 2013-10-01 | 2013-11-11 | 2367045 FS-31d | 86d | 68d | 8/5 M-F w/JLAB Holidays ReBaseline | ELEC TECH [64 h]; ELEC ENG [22.4 h] | 4,690.27 | GARZA O | 1 | 1 | MIKE S | 10-070 | 10-031 | 10-065 | 12-035 | 12-053 |  |  | 13-003 |  |  | 2367050 | PE | 13-015 | PR | 14-001 | PE |
| 2367055 |  | Magnet Communication New I/O IP Software -Labor | 30d | 2013-10-01 | 2013-11-11 | 2367045 FS-31d | 14d |  | 8/5 M-F w/JLAB Holidays ReBaseline | ELEC ENG [92.8 h] | 6,972.06 | GARZA O | 1 | 1 | MIKE S | 10-070 | 10-031 | 10-065 | 12-035 | 12-053 |  |  | 13-003 |  |  | 2367055 | PE | 13-015 | PR | 14-001 |  |
| 2367035 |  | Magnet Communication New I/O IP design - Proc. | 31d | 2013-10-02 | 2013-11-13 | 2367030 FS-31d, 2367030a FS-31d | 14d | 0d | 8/5 M-F w/JLAB Holidays ReBaseline | ELEC ENG [8.4 h]; PROCUREMENT<$50K 60; ELEC TECH [12 h] | 4,600.24 | GARZA O | 1 | 1 | MIKE S | 10-070 | 10-031 | 10-065 | 12-035 | 12-053 |  |  | 13-003 |  |  | 2367035 | PE | 13-015 | PR | 14-001 | PE |
| 2367040 |  | Magnet Communication New I/O IP Fabrication | 31d | 2013-10-02 | 2013-11-13 | 2367035 FS-31d | 14d | 0d | 8/5 M-F w/JLAB Holidays ReBaseline | PROCUREMENT<$50K 60; ELEC TECH [144 h] | 9,243.12 | GARZA O | 1 | 1 | MIKE S | 10-070 | 10-031 | 10-065 | 12-035 | 12-053 |  |  | 13-003 |  |  | 2367040 | PE | 13-015 | PR | 14-001 | PE |
| 2367045 |  | Magnet Communication New I/O IP Testing | 30d | 2013-10-02 | 2013-11-12 | 2367040 FS-31d | 14d | 0d | 8/5 M-F w/JLAB Holidays ReBaseline | ELEC TECH [64 h]; ELEC ENG [22.4 h] | 4,690.27 | GARZA O | 1 | 1 | MIKE S | 10-070 | 10-031 | 10-065 | 12-035 | 12-053 |  |  | 13-003 |  |  | 2367045 | PE | 13-015 | PR | 14-001 | PE |

Notes:
- 1367025: Entry Criteria: Ext Pred: Magnet IOCs and / network installed and useable
- 1367020: Entry Criteria: Ext Pred: Corresponding magnets, power supplies and beamline / installed
- 1367020b: Entry Criteria: Ext Pred: Corresponding magnets, power supplies and beamline / installed
- 1367020a: Entry Criteria: Ext Pred: Corresponding magnets, power supplies and beamline / installed
- 1367025a: Entry Criteria: Ext Pred: Magnet IOCs and / network installed and useable
- 1367030: Entry Criteria: Ext Pred: Magnet IOCs and / network installed and useable
- 1367035: Entry Criteria: Ext Pred: Magnet IOCs and / network installed and useable
- 1367040: Entry Criteria: Ext Pred: Magnet IOCs and / network installed and useable
- 1367045: Entry Criteria: Ext Pred: Magnet IOCs and / network installed and useable
- 1367050: Entry Criteria: Ext Pred: Magnet IOCs and / network installed and useable
- 1367055: Entry Criteria: Ext Pred: Magnet IOCs and / network installed and useable
- 2367025a: Entry Criteria: Ext Pred: Magnet IOCs and / network installed and useable
- 2367030: Entry Criteria: Ext Pred: Magnet IOCs and / network installed and useable
- 2367025aa: Entry Criteria: Ext Pred: Magnet IOCs and / network installed and useable
- 2367030a: Entry Criteria: Ext Pred: Magnet IOCs and / network installed and useable
- 2367050: Entry Criteria: Ext Pred: Magnet IOCs and / network installed and useable
- 2367055: Entry Criteria: Ext Pred: Magnet IOCs and / network installed and useable
- 2367035: Entry Criteria: Ext Pred: Magnet IOCs and / network installed and useable
- 2367040: Entry Criteria: Ext Pred: Magnet IOCs and / network installed and useable
- 2367045: Entry Criteria: Ext Pred: Magnet IOCs and / network installed and useable

| ID | WBS | Activity | Duration | Start | Finish | Predecessors | Total float | Free float | RESP - Responsibility | STRT%COMP for CM EVM | FNSH%COMP for CM EVM | CR 07-024 | CAM RESPONSIBLE | CR 09-012 | CR 11-026 | PHAS - Project Phase | CR 13-014 |
| --- | --- | --- | --- | --- | --- | --- | --- | --- | --- | --- | --- | --- | --- | --- | --- | --- | --- |
|  | 4 | **1.4 CONSTRUCTION UPGRADE HALLS A, B, & C** |  | 2008-10-01 | 2016-02-03 |  |  |  |  |  |  |  |  |  |  |  |  |
|  | 1 | **1.4.1 CONSTRUCTION HALL A** |  | 2008-10-01 | 2013-09-30 |  |  |  |  |  |  |  |  |  |  |  |  |
|  | 1 | **1.4.1.1 MAGNET** |  |  |  |  |  |  |  |  |  |  |  |  |  |  |  |
|  | 1 | **1.4.1.1.1 COMBINED FUNCTION MAGNET** |  |  |  |  |  |  |  |  |  |  |  |  |  |  |  |
|  | 2 | **1.4.1.1.2 CRYOGENIC SYSTEM** |  |  |  |  |  |  |  |  |  |  |  |  |  |  |  |
|  | 3 | **1.4.1.1.3 POWER SUPPLY INFRASTRUCTURE** |  |  |  |  |  |  |  |  |  |  |  |  |  |  |  |
|  | 4 | **1.4.1.1.4 SHIELD HOUSE** |  |  |  |  |  |  |  |  |  |  |  |  |  |  |  |
|  | 5 | **1.4.1.1.5 SUPPORT STRUCTURE & MOTION SYSTEM** |  |  |  |  |  |  |  |  |  |  |  |  |  |  |  |
|  | 6 | **1.4.1.1.6 CONTROL SYSTEM** |  |  |  |  |  |  |  |  |  |  |  |  |  |  |  |
|  | 7 | **1.4.1.1.7 MAD SEPTUM** |  |  |  |  |  |  |  |  |  |  |  |  |  |  |  |
|  | 2 | **1.4.1.2 DETECTOR** |  |  |  |  |  |  |  |  |  |  |  |  |  |  |  |
|  | 1 | **1.4.1.2.1 TRIGGER SYSTEM (Scintillators)** |  |  |  |  |  |  |  |  |  |  |  |  |  |  |  |
|  | 2 | **1.4.1.2.2 TRACKING SYSTEM (Drift Chambers)** |  |  |  |  |  |  |  |  |  |  |  |  |  |  |  |
|  | 3 | **1.4.1.2.3 GAS CERENKOV** |  |  |  |  |  |  |  |  |  |  |  |  |  |  |  |
|  | 4 | **1.4.1.2.4 AEROGEL CERENKOV** |  |  |  |  |  |  |  |  |  |  |  |  |  |  |  |
|  | 5 | **1.4.1.2.5 CALORIMETER** |  |  |  |  |  |  |  |  |  |  |  |  |  |  |  |
|  | 6 | **1.4.1.2.6 FOCAL PLANE POLARIMETER** |  |  |  |  |  |  |  |  |  |  |  |  |  |  |  |
|  | 3 | **1.4.1.3 COMPUTING** |  | 2008-10-01 | 2013-08-30 |  |  |  |  |  |  |  |  |  |  |  |  |
|  | 1 | **1.4.1.3.1 DAQ FOR MAD** |  |  |  |  |  |  |  |  |  |  |  |  |  |  |  |
|  | 2 | **1.4.1.3.2 DAQ UPGRADES FOR HRS** |  | 2008-10-01 | 2013-08-30 |  |  |  |  |  |  |  |  |  |  |  |  |
| 14132909LOE |  | FY09 Proj Admin H-A, All Constrctn (DAQ UPGRADES) | 248d | 2008-10-01 | 2009-09-30 | 122132908LOE | 20d | 0d | LEROSE J | 1 | 1 | 07-024 | JOHN L | 09-012 |  |  |  |
| 14132910LOE |  | FY10 Proj Admin H-A, All Constrctn (DAQ UPGRADES) | 248d | 2009-10-01 | 2010-09-30 | 14132909LOE | 20d | 0d | LEROSE J | 1 | 1 | 07-024 | JOHN L | 09-012 |  |  |  |
| 14132911LOE |  | FY11 Proj Admin H-A, All Constrctn (DAQ UPGRADES) | 248d | 2010-10-01 | 2011-09-30 | 14132910LOE | 20d | 0d | LEROSE J | 1 | 1 | 07-024 | JOHN L | 09-012 |  |  |  |
| 14132018 |  | Proc ADCs, TDCs,¿ (DAQ UPGRADES) | 80d | 2011-01-05 | 2011-04-28 | 9-110M FS+60d | 581d | 168d | LEROSE J | 1 | 1 | 07-024 | JOHN L | 09-012 | 11-026 |  |  |
| 14132912LOE |  | FY12 Proj Admin H-A, All Constrctn (DAQ UPGRADES) | 247d | 2011-10-03 | 2012-09-28 | 14132911LOE | 20d | 0d | LEROSE J | 1 | 1 | 07-024 | JOHN L | 09-012 |  |  |  |
| 14132020 |  | Install Electrnc's (DAQ UPGRADES) | 79d | 2012-01-05 | 2012-04-26 | 14132018, 9-120M FS+60d | 413d | 141d | LEROSE J | 1 | 1 | 07-024 | JOHN L | 09-012 | 11-026 | IN |  |
| 14132913LOE |  | FY13 Proj Admin H-A, All Constrctn (DAQ UPGRADES) | 228d | 2012-10-01 | 2013-08-30 | 14132912LOE | 20d |  | LEROSE J | 1 | 1 | 07-024 | JOHN L | 09-012 |  |  | 13-014 |

| ID | WBS | Activity | Type | Duration | Start | Finish | Predecessors | Total float | Free float | Calendar | Resources | Cost | RESP - Responsibility | STRT%COMP for CM EVM | FNSH%COMP for CM EVM | Milestone Level | CAM RESPONSIBLE | CR 10-048 | PHAS - Project Phase | CR 11-026 | CR 11-038 | CR 11-039 | CR 12-053 | CR 13-014 | ReBaseline Actuals Adjustment | BOE NOTES | Original Activity ID Rebaseline | Over Under Fixed | BOE Procurement | BOE Adder | CR 13-015 | Post Rebaseline | Obligated Prior to Rebaseline | Pre Rebaseline Remaining Budget | BOE Labor | BOE Expenses | Previously In Progress |
| --- | --- | --- | --- | --- | --- | --- | --- | --- | --- | --- | --- | --- | --- | --- | --- | --- | --- | --- | --- | --- | --- | --- | --- | --- | --- | --- | --- | --- | --- | --- | --- | --- | --- | --- | --- | --- | --- |
|  | 4 | **1.4.1.4 FAST ELECTRONICS** |  |  |  |  |  |  |  |  |  |  |  |  |  |  |  |  |  |  |  |  |  |  |  |  |  |  |  |  |  |  |  |  |  |  |  |
|  | 5 | **1.4.1.5 BEAMLINE** |  |  | 2011-10-03 | 2013-09-30 |  |  |  |  |  |  |  |  |  |  |  |  |  |  |  |  |  |  |  |  |  |  |  |  |  |  |  |  |  |  |  |
|  | 1 | **1.4.1.5.1 MOLLER POLARIMETER** |  |  | 2011-10-03 | 2013-08-30 |  |  |  |  |  |  |  |  |  |  |  |  |  |  |  |  |  |  |  |  |  |  |  |  |  |  |  |  |  |  |  |
| 14151000M |  | Start Moller polarimeter upgrade (MOL POLAR) | milestone | 0d | 2011-10-03 | 2011-10-03 | 9-120M | 5d | 0d |  |  |  | LEROSE J | 1 | 1 | 6 | JOHN L | 10-048 |  |  |  |  |  |  |  |  |  |  |  |  |  |  |  |  |  |  |  |
| 14151015 |  | Prepare Quadrupole Manufacturing Drawings Package |  | 15d | 2011-10-03 | 2011-10-21 | 9-120M | 273d | 0d |  | MECH DES [120 h] | 5,780.4 | LEROSE J | 1 | 1 |  | JOHN L |  | IN | 11-026 | 11-038 | 11-039 |  |  |  |  |  |  |  |  |  |  |  |  |  |  |  |
| 14151020 |  | Quadrupole Procurement prep |  | 56d | 2011-10-24 | 2012-01-20 | 14151015 | 273d | 0d |  | MECH ENG [80 h] | 5,609.6 | LEROSE J | 1 | 1 |  | JOHN L |  | IN | 11-026 | 11-038 | 11-039 |  |  |  |  |  |  |  |  |  |  |  |  |  |  |  |
| 14151005 |  | Proc Compnts - Stands, Magnetic Shield insert,... (MOL POLAR) |  | 100d | 2011-12-07 | 2012-05-04 | 14151000M FS+45d | 5d | 0d |  | PROCUREMENT<$50K 60 | 49,502.95 | LEROSE J | 1 | 1 |  | JOHN L | 10-048 |  |  |  |  |  |  |  |  |  |  |  |  |  |  |  |  |  |  |  |
| 14151025 |  | Quadrupole Contract Support |  | 157d | 2012-01-23 | 2012-08-31 | 14151020 | 273d | 1d |  | MECH ENG [160 h] | 11,219.2 | LEROSE J | 1 | 1 |  | JOHN L |  | IN | 11-026 | 11-038 | 11-039 |  |  |  |  |  |  |  |  |  |  |  |  |  |  |  |
| 14151030 |  | Vend Fab Quadrupole |  | 157d | 2012-01-23 | 2012-08-31 | 14151020 | 273d | 1d |  | PROCUREMENT<$50K 60 | 41,276 | LEROSE J | 1 | 1 |  | JOHN L |  | IN | 11-026 | 11-038 | 11-039 |  |  |  |  |  |  |  |  |  |  |  |  |  |  |  |
| 14151035 |  | Procure/Refurbish Power Supply for Quadrupole |  | 157d | 2012-01-23 | 2012-08-31 | 14151020 | 273d | 1d |  | PROCUREMENT<$50K 60 | 6,088.21 | LEROSE J | 1 | 1 |  | JOHN L |  | IN | 11-026 | 11-038 | 11-039 |  |  |  |  |  |  |  |  |  |  |  |  |  |  |  |
| 14151010 |  | Install Modifications (MOL POLAR) FY12 |  | 97d | 2012-05-14 | 2012-09-28 | 3P-01M, 2-02M, 14151035 FS-79d, 14151025 FS-79d, 14151030 FS-79d, 14151005 | 272d | 0d |  | COMP SCIENT [29.85 h]; SUPPLIES & MATERIALS; VISTNG USERS [119.38 h]; SKLLD TRADE [59.69 h]; SCIENTIST [119.38 h]; PLABOR; ELEC TECH [29.85 h] | 19,973.15 | LEROSE J | 1 | 1 |  | JOHN L |  | IN | 11-026 | 11-038 |  | 12-053 |  |  |  |  |  |  |  |  |  |  |  |  |  |  |
| 14151010a |  | Install Modifications (MOL POLAR) FY13 |  | 33d | 2012-10-01 | 2012-11-14 | 14151010 | 272d | 0d |  | COMP SCIENT [10.15 h]; SUPPLIES & MATERIALS; VISTNG USERS [40.62 h]; SKLLD TRADE [20.31 h]; SCIENTIST [40.62 h]; PLABOR; ELEC TECH [10.15 h] | 7,011.93 | LEROSE J | 1 | 1 |  | JOHN L |  | IN | 11-026 | 11-038 |  | 12-053 |  |  |  |  |  |  |  |  |  |  |  |  |  |  |
| 14151040 |  | Re-Baseline Actuals Adjustment |  | 1d | 2013-08-30 | 2013-08-30 | 9-130M FS+227d | 20d |  |  | PROCUREMENT>$50K 69 NO ESCALATION | 76,452.76 | LEROSE J | 1 | 1 |  | JOHN L |  |  |  |  |  |  | 13-014 | ADJ |  |  |  |  |  |  |  |  |  |  |  |  |
|  | 2 | **1.4.1.5.2 COMPTON POLARIMETER** |  |  | 2011-10-03 | 2013-09-30 |  |  |  |  |  |  |  |  |  |  |  |  |  |  |  |  |  |  |  |  |  |  |  |  |  |  |  |  |  |  |  |
| 14152000M |  | Start Compton upgrade (COMP POLAR) | milestone | 0d | 2011-10-03 | 2011-10-03 | 122152020, 9-120M | 90d | 0d |  |  |  | LEROSE J | 1 | 1 | 6 | JOHN L | 10-048 |  | 11-026 |  |  |  |  |  |  |  |  |  |  |  |  |  |  |  |  |  |
| 14152005 |  | Proc Detector componets (COMP POLAR) |  | 80d | 2011-10-03 | 2012-02-02 | 14152000M | 272d | 0d |  | PROCUREMENT<$50K 60 | 108,670.15 | LEROSE J | 1 | 1 |  | JOHN L | 10-048 |  | 11-026 |  |  |  |  |  |  |  |  |  |  |  |  |  |  |  |  |  |
| 14152015 |  | Proc motion sys, Stands & Beam Line (COMP POLAR) |  | 60d | 2011-10-03 | 2012-01-04 | 14152000M | 90d | 85d |  | PROCUREMENT<$50K 60 | 77,150.2 | LEROSE J | 1 | 1 |  | JOHN L | 10-048 |  |  |  |  |  |  |  |  |  |  |  |  |  |  |  |  |  |  |  |
| 14152010 |  | Assemble & Test Detector (COMP POLAR) |  | 70d | 2012-02-03 | 2012-05-11 | 14152005 | 272d | 0d |  | PD UNIV STAFF [80 h]; SCIENTIST [160 h]; PD UNIV STUDNT [200 h]; ELEC TECH [40 h] | 19,692 | LEROSE J | 1 | 1 |  | JOHN L | 10-048 |  | 11-026 |  |  |  |  |  |  |  |  |  |  |  |  |  |  |  |  |  |
| 14152020 |  | Install & Test (COMP POLAR) FY12 |  | 97d | 2012-05-14 | 2012-09-28 | 14152015, 3P-01M, 2-02M, 14152010 | 272d | 0d |  | PD UNIV STUDNT [149.23 h]; SCIENTIST [179.08 h]; SKLLD TRADE [119.38 h]; ELEC TECH [89.54 h]; PD UNIV STAFF [59.69 h]; MECH TECH [835.69 h] | 62,673.82 | LEROSE J | 1 | 1 |  | JOHN L |  | IN | 11-026 |  |  | 12-053 |  |  |  |  |  |  |  |  |  |  |  |  |  |  |
| 14152025 |  | Install & Test (COMP POLAR) FY13 |  | 33d | 2012-10-01 | 2012-11-14 | 14152020 | 272d | 0d |  | PD UNIV STUDNT [50.77 h]; SCIENTIST [60.92 h]; SKLLD TRADE [40.62 h]; ELEC TECH [30.46 h]; PD UNIV STAFF [20.31 h]; MECH TECH [284.31 h] | 22,002.99 | LEROSE J | 1 | 1 |  | JOHN L |  | IN | 11-026 |  |  | 12-053 |  |  |  |  |  |  |  |  |  |  |  |  |  |  |
| 14152030 |  | Re-Baseline Actuals Adjustment |  | 1d | 2013-08-30 | 2013-08-30 | 9-130M FS+227d | 20d |  |  | PROCUREMENT>$50K 69 NO ESCALATION | 15,961.76 | LEROSE J | 1 | 1 |  | JOHN L |  |  |  |  |  |  | 13-014 | ADJ |  |  |  |  |  |  |  |  |  |  |  |  |
| 24152015 |  | Proc motion sys, Stands & Beam Line (COMP POLAR) Re-Baseline Obligation Split |  | 20d | 2013-09-03 | 2013-09-30 | 9-130M FS+228d | 57d | 0d | 8/5 M-F w/JLAB Holidays ReBaseline | PROCUREMENT<$50K 60 | 12 | LEROSE J | 1 | 1 |  | JOHN L | 10-048 |  |  |  |  |  |  |  | This is essentially done | 24152015 | y | OB | NO | 13-015 | PR | OB |  |  |  |  |
| 24152020 |  | Proc motion sys, Stands & Beam Line (COMP POLAR) |  | 20d | 2013-09-03 | 2013-09-30 | 9-130M FS+228d | 57d | 0d | 8/5 M-F w/JLAB Holidays ReBaseline | PROCUREMENT<$50K 60 | 3,845.51 | LEROSE J | 1 | 1 |  | JOHN L | 10-048 |  |  |  |  |  |  |  | This is essentially done | 24152015 |  | OB | NO | 13-015 | PR |  |  |  |  |  |
| 24152025 |  | Install & Test (COMP POLAR) |  | 20d | 2013-09-03 | 2013-09-30 | 24152020 FS-20d, 24152015 FS-20d | 57d | 9d | 8/5 M-F w/JLAB Holidays ReBaseline | MECH DES [40 h]; MECH TECH [80 h] | 5,657.2 | LEROSE J | 1 | 1 |  | JOHN L |  | IN | 11-026 |  |  | 12-053 |  |  | work in progress | 24152025 |  |  | NO | 13-015 | PR |  | 82136.51 | PE | PE | Review |

| ID | WBS | Activity | Type | Duration | Start | Finish | Predecessors | Total float | Free float | Calendar | Resources | Cost | RESP - Responsibility | STRT%COMP for CM EVM | FNSH%COMP for CM EVM | Milestone Level | CAM RESPONSIBLE | CR 10-048 | CR 11-026 | PHAS - Project Phase | CR 08-010 | CR 09-012 | CR 10-030 | CR 13-014 | ReBaseline Actuals Adjustment | BOE NOTES | Original Activity ID Rebaseline | BOE Adder | CR 13-015 | Post Rebaseline | CR 07-024 | CR 08-058 | 12 GeV 4th level Critical Path | Advance Purchase Plan > 500K | CR 08-016 | 12 GEV MAJOR PROCUREMENT CATAGORY | CR 09-049 | CR 11-035 | CR 13-002 | CR 12-024 | CR 08-039 | CR 10-044 | CR 11-023 | Schedule Contingency | CR 11-001 | CR 12-001 | CR 12-053 | Over Under Fixed | CR 12-055 | BOE Procurement | Obligated Prior to Rebaseline | CR 13-016 |
| --- | --- | --- | --- | --- | --- | --- | --- | --- | --- | --- | --- | --- | --- | --- | --- | --- | --- | --- | --- | --- | --- | --- | --- | --- | --- | --- | --- | --- | --- | --- | --- | --- | --- | --- | --- | --- | --- | --- | --- | --- | --- | --- | --- | --- | --- | --- | --- | --- | --- | --- | --- | --- |
|  | 3 | **1.4.1.5.3 MAPPING-ARC ENERGY MEASUREMENT** |  |  | 2012-05-14 | 2013-09-03 |  |  |  |  |  |  |  |  |  |  |  |  |  |  |  |  |  |  |  |  |  |  |  |  |  |  |  |  |  |  |  |  |  |  |  |  |  |  |  |  |  |  |  |  |  |  |
| 14153000M |  | Start Mapper Constr (MAPPER) | milestone | 0d | 2012-05-14 | 2012-05-14 | 122153010, 2-02M, 9-110M | 341d | 0d |  |  |  | LEROSE J | 1 | 1 | 6 | JOHN L | 10-048 | 11-026 |  |  |  |  |  |  |  |  |  |  |  |  |  |  |  |  |  |  |  |  |  |  |  |  |  |  |  |  |  |  |  |  |  |
| 14153010 |  | Calibrate H-A Line Magnets (MAPPER) |  | 60d | 2012-05-14 | 2012-08-07 | 14153000M, 2-02M | 341d | 0d |  | PD UNIV STUDNT [600 h]; VISTNG USERS [480 h]; TRAVEL; SCIENTIST [480 h]; MECH TECH [608 h]; ELEC TECH [88 h]; SUPPLIES & MATERIALS | 88,413 | LEROSE J | 1 | 1 |  | JOHN L | 10-048 | 11-026 | IN | 08-010 | 09-012 | 10-030 |  |  |  |  |  |  |  |  |  |  |  |  |  |  |  |  |  |  |  |  |  |  |  |  |  |  |  |  |  |
| 14153020 |  | Install Mapper & Rebuilt 9th Dipole in Shed (MAPPER) |  | 1d | 2012-08-08 | 2012-08-08 | 14153010 | 341d | 69d |  |  |  | LEROSE J | 1 | 1 |  | JOHN L | 10-048 | 11-026 | IN | 08-010 | 09-012 | 10-030 |  |  |  |  |  |  |  |  |  |  |  |  |  |  |  |  |  |  |  |  |  |  |  |  |  |  |  |  |  |
| 14153025 |  | Re-Baseline Actuals Adjustment |  | 1d | 2013-08-30 | 2013-08-30 | 9-130M FS+227d | 20d |  |  | PROCUREMENT>$50K 69 NO ESCALATION | -27,482.98 | LEROSE J | 1 | 1 |  | JOHN L |  |  |  |  |  |  | 13-014 | ADJ |  |  |  |  |  |  |  |  |  |  |  |  |  |  |  |  |  |  |  |  |  |  |  |  |  |  |  |
| 24153020 |  | Install Rebuilt 9th Dipole in Shed (MAPPER) |  | 1d | 2013-09-03 | 2013-09-03 | 9-130M FS+228d | 76d | 28d | 8/5 M-F w/JLAB Holidays ReBaseline |  |  | LEROSE J | 1 | 1 |  | JOHN L | 10-048 | 11-026 | IN | 08-010 | 09-012 | 10-030 |  |  | This is never going to happen (HELLO!) | 24153020 | NO | 13-015 | PR |  |  |  |  |  |  |  |  |  |  |  |  |  |  |  |  |  |  |  |  |  |  |
|  | 6 | **1.4.1.6 INFRASTRUCTURE** |  |  |  |  |  |  |  |  |  |  |  |  |  |  |  |  |  |  |  |  |  |  |  |  |  |  |  |  |  |  |  |  |  |  |  |  |  |  |  |  |  |  |  |  |  |  |  |  |  |  |
|  | 1 | **1.4.1.6.1 ENGINEERING & DESIGN** |  |  |  |  |  |  |  |  |  |  |  |  |  |  |  |  |  |  |  |  |  |  |  |  |  |  |  |  |  |  |  |  |  |  |  |  |  |  |  |  |  |  |  |  |  |  |  |  |  |  |
|  | 2 | **1.4.1.6.2 CABLING** |  |  |  |  |  |  |  |  |  |  |  |  |  |  |  |  |  |  |  |  |  |  |  |  |  |  |  |  |  |  |  |  |  |  |  |  |  |  |  |  |  |  |  |  |  |  |  |  |  |  |
|  | 3 | **1.4.1.6.3 INSTALLATION** |  |  |  |  |  |  |  |  |  |  |  |  |  |  |  |  |  |  |  |  |  |  |  |  |  |  |  |  |  |  |  |  |  |  |  |  |  |  |  |  |  |  |  |  |  |  |  |  |  |  |
|  | 2 | **1.4.2 CONSTRUCTION HALL B** |  |  | 2008-10-01 | 2016-01-28 |  |  |  |  |  |  |  |  |  |  |  |  |  |  |  |  |  |  |  |  |  |  |  |  |  |  |  |  |  |  |  |  |  |  |  |  |  |  |  |  |  |  |  |  |  |  |
|  | 1 | **1.4.2.1 MAGNET** |  |  | 2009-01-02 | 2013-09-30 |  |  |  |  |  |  |  |  |  |  |  |  |  |  |  |  |  |  |  |  |  |  |  |  |  |  |  |  |  |  |  |  |  |  |  |  |  |  |  |  |  |  |  |  |  |  |
|  | 1 | **1.4.2.1.1 TOROIDAL MAGNET** |  |  | 2009-01-02 | 2013-09-30 |  |  |  |  |  |  |  |  |  |  |  |  |  |  |  |  |  |  |  |  |  |  |  |  |  |  |  |  |  |  |  |  |  |  |  |  |  |  |  |  |  |  |  |  |  |  |
| 14211009E |  | Torus FY09 Travel |  | 189d | 2009-01-02 | 2009-09-30 | 14211009EX | 0d |  |  | TRAVEL | 6,086.21 | ELOUADRHIRI L | 1 | 1 |  | LATIFA E |  |  |  |  |  |  |  |  |  |  |  |  |  | 07-024 | 08-058 |  |  |  |  |  |  |  |  |  |  |  |  |  |  |  |  |  |  |  |  |
| 14211004 |  | Torus Vend Comp Dsgn & Fab FY09 Original Labor Initial |  | 167d | 2009-01-05 | 2009-08-31 | 14211000MX, 14211002X FS+1d | 830d | 81d |  | SCIENTIST [190.86 h]; MECH TECH [545.31 h]; ELEC ENG [136.33 h]; ELEC DES [190.86 h]; ELEC TECH [54.53 h]; OFFICE [54.5 h]; MECH ENG [245.39 h]; MECH DES [163.59 h] | 78,291.18 | ELOUADRHIRI L | 1 | 1 |  | LATIFA E |  | 11-026 |  |  | 09-012 |  |  |  |  |  |  |  |  |  |  | 4 | APP | 08-016 | 4211 | 09-049 | 11 -035 | 13-002F |  |  |  |  |  |  |  |  |  |  |  |  |  |
| 14211004A |  | Torus Vend Comp Dsgn & Fab FY09 Original Labor Final |  | 21d | 2009-09-01 | 2009-09-30 | 9-090M FS+227d | 752d | 0d |  | ELEC TECH [6.86 h]; MECH DES [20.57 h]; MECH ENG [30.86 h]; MECH TECH [68.57 h]; OFFICE [6.86 h]; SCIENTIST [24 h]; ELEC DES [24 h]; ELEC ENG [17.14 h] | 9,845.08 | ELOUADRHIRI L | 1 | 1 |  | LATIFA E |  | 11-026 |  |  |  |  |  |  |  |  |  |  |  |  |  | 4 | APP |  | 4211 | 09-049 | 11 -035 | 13-002F |  |  |  |  |  |  |  |  |  |  |  |  |  |
| 14211030 |  | Vend Fab Torus - Completion of System Requirements Review (SRR) |  | 40d | 2009-09-04 | 2009-10-30 | 9-090M FS+230d | 1220d | 0d |  | PROCUREMENT<$50K 60 NO ESCALATION; PROCUREMENT>$50K 69 NO ESCALATION | 112,000 | ELOUADRHIRI L | 1 | 1 |  | LATIFA E |  | 11-026 |  |  | 09-012 |  |  |  |  |  |  |  |  |  |  |  | APP | 08-016 | 4211 | 09-049 | 11 -035 | 13-002F | 12-024F |  |  |  |  |  |  |  |  |  |  |  |  |
| 14211035 |  | Vend Fab Torus - Completion of Preliminary Design Review |  | 76d | 2009-09-04 | 2009-12-30 | 14211030 FS-40d | 1220d | 0d |  | PROCUREMENT>$50K 69 NO ESCALATION | 274,000 | ELOUADRHIRI L | 1 | 1 |  | LATIFA E |  | 11-026 |  |  | 09-012 |  |  |  |  |  |  |  |  |  |  |  | APP | 08-016 | 4211 | 09-049 | 11 -035 | 13-002F | 12-024F | 08-039 |  |  |  |  |  |  |  |  |  |  |  |
| 14211040 |  | Vend Fab Torus - Superconductor Production |  | 96d | 2009-09-04 | 2010-01-29 | 14211035 FS-76d | 1220d | 20d |  | PROCUREMENT>$50K 69 NO ESCALATION | 262,000 | ELOUADRHIRI L | 1 | 1 |  | LATIFA E |  | 11-026 |  |  | 09-012 |  |  |  |  |  |  |  |  |  |  |  | APP | 08-016 | 4211 | 09-049 | 11 -035 | 13-002F | 12-024F |  | 10-044 |  |  |  |  |  |  |  |  |  |  |
| 14211045 |  | Vend Fab Torus - Completion of Preliminary Design Review and Manufacturing Readiness Review |  | 115d | 2009-09-04 | 2010-02-26 | 14211040B FS-288d, 14211040A FS-116d, 14211040 FS-116d | 1200d | 0d |  | PROCUREMENT>$50K 69 NO ESCALATION | 324,000 | ELOUADRHIRI L | 1 | 1 |  | LATIFA E |  | 11-026 | IN |  | 09-012 |  |  |  |  |  |  |  |  |  |  |  | APP | 08-016 | 4211 | 09-049 | 11 -035 | 13-002F | 12-024F |  | 10-044 |  |  |  |  |  |  |  |  |  |  |
| 14211004B |  | Torus Vend Comp Dsgn & Fab FY10 Original Labor |  | 57d | 2009-10-01 | 2009-12-29 | 14211004A | 752d | 3d |  | MECH DES [55.84 h]; SCIENTIST [65.14 h]; MECH TECH [186.12 h]; OFFICE [18.61 h]; MECH ENG [83.75 h]; ELEC DES [65.14 h]; ELEC TECH [18.61 h]; ELEC ENG [46.53 h] | 27,573.31 | ELOUADRHIRI L | 1 | 1 |  | LATIFA E |  | 11-026 |  |  |  |  |  |  |  |  |  |  |  |  |  | 4 | APP |  | 4211 | 09-049 | 11 -035 | 13-002F |  |  |  |  |  |  |  |  |  |  |  |  |  |
| 14211010E |  | Torus FY10 Travel |  | 248d | 2009-10-01 | 2010-09-30 | 14211009E | 0d |  |  | TRAVEL | 8,240.89 | ELOUADRHIRI L | 1 | 1 |  | LATIFA E |  |  |  |  |  |  |  |  |  |  |  |  |  | 07-024 |  |  |  |  |  |  |  |  |  |  |  |  |  |  |  |  |  |  |  |  |  |
| 14211040C |  | Vend Fab Torus -Solder Stabilizer Production |  | 367d | 2009-11-02 | 2011-04-29 | 14211040B FS-247d | 1155d | 1152d |  | PROCUREMENT>$50K 69 NO ESCALATION | 70,000 | ELOUADRHIRI L | 1 | 1 |  | LATIFA E |  | 11-026 |  |  |  |  |  |  |  |  |  |  |  |  |  |  | APP |  | 4211 |  | 11 -035 | 13-002F | 12-024F |  | 10-044 | 11-023 |  |  |  |  |  |  |  |  |  |
| 14211050 |  | Vend Fab Torus -Design and Construction of Prototype Coil (Full Size) |  | 304d | 2009-11-02 | 2011-01-31 | 14211045 FS-75d, 14211045D FS-340d, 14211045A FS-76d | 1200d | 0d |  | PROCUREMENT>$50K 69 NO ESCALATION; PROCUREMENT<$50K 60 NO ESCALATION | 203,000 | ELOUADRHIRI L | 1 | 1 |  | LATIFA E |  | 11-026 | IN |  |  |  |  |  |  |  |  |  |  |  |  |  | APP |  | 4211 | 09-049 | 11 -035 | 13-002F | 12-024F |  | 10-044 |  | SC |  |  |  |  |  |  |  |  |
| 14211050A |  | Vend Fab Torus - Testing of Prototype Coil (Full Size) |  | 346d | 2009-11-02 | 2011-03-31 | 14211045A FS-76d, 14211045D FS-340d, 14211045 FS-75d | 1200d | 0d |  | PROCUREMENT>$50K 69 NO ESCALATION | 203,000 | ELOUADRHIRI L | 1 | 1 |  | LATIFA E |  | 11-026 | IN |  |  |  |  |  |  |  |  |  |  |  |  |  | APP |  | 4211 |  | 11 -035 | 13-002F | 12-024F |  | 10-044 |  | SC |  |  |  |  |  |  |  |  |
| 14211050Ab |  | Vend Fab Torus - Stability Model Coil test |  | 367d | 2009-11-02 | 2011-04-29 | 14211050A FS-346d | 1319d | 0d |  | PROCUREMENT>$50K 69 NO ESCALATION | 55,409 | ELOUADRHIRI L | 1 | 1 |  | LATIFA E |  | 11-026 | IN |  |  |  |  |  |  |  |  |  |  |  |  |  | APP |  | 4211 |  | 11 -035 | 13-002F | 12-024F |  | 10-044 | 11-023 | SC |  |  |  |  |  |  |  |  |
| 14211050Ac |  | Vend Fab Torus - UG&GUG Duties |  | 323d | 2009-11-02 | 2011-02-28 | 14211050Ab FS-367d | 1319d | 0d |  | PROCUREMENT>$50K 69 NO ESCALATION | 101,459 | ELOUADRHIRI L | 1 | 1 |  | LATIFA E |  | 11-026 | IN |  |  |  |  |  |  |  |  |  |  |  |  |  | APP |  | 4211 |  | 11 -035 | 13-002F | 12-024F |  | 10-044 | 11-023 | SC |  |  |  |  |  |  |  |  |
| 14211050Ad |  | Vend Fab Torus - Coil Case Plates-Mill run Phase 2 Funding |  | 346d | 2009-11-02 | 2011-03-31 | 14211050Ac FS-323d | 1319d | 0d |  | PROCUREMENT>$50K 69 NO ESCALATION | 41,532 | ELOUADRHIRI L | 1 | 1 |  | LATIFA E |  | 11-026 | IN |  |  |  |  |  |  |  |  |  |  |  |  |  | APP |  | 4211 |  | 11 -035 | 13-002F | 12-024F |  | 10-044 | 11-023 | SC |  |  |  |  |  |  |  |  |
| 14211055 |  | Vend Fab Torus -Complete and Warm Test Coil #1 |  | 532d | 2009-11-02 | 2011-12-30 | 14211050 FS-304d, 14211050A FS-346d | 1200d | 0d |  | PROCUREMENT>$50K 69 NO ESCALATION | 282,600 | ELOUADRHIRI L | 1 | 1 |  | LATIFA E |  | 11-026 | IN |  |  |  |  |  |  |  |  |  |  |  |  |  | APP |  | 4211 | 09-049 | 11 -035 | 13-002F | 12-024F |  | 10-044 | 11-023 | SC |  |  |  |  |  |  |  |  |
| 14211060 |  | Vend Fab Torus -Complete and Warm Test Coil #2 |  | 572d | 2009-11-02 | 2012-02-29 | 14211055 FS-532d | 1200d | 0d |  | PROCUREMENT>$50K 69 NO ESCALATION | 235,000 | ELOUADRHIRI L | 1 | 1 |  | LATIFA E |  | 11-026 | IN |  |  |  |  |  |  |  |  |  |  |  |  |  | APP |  | 4211 | 09-049 | 11 -035 | 13-002F | 12-024F |  | 10-044 | 11-023 | SC |  |  |  |  |  |  |  |  |
| 14211010 |  | Torus Vend Coil Winding Original Labor FY10 |  | 188d | 2010-01-05 | 2010-09-30 | 14211004, 14211004B, 9-100M FS+60d | 749d | 0d |  | MECH ENG [276.24 h]; MECH TECH [767.35 h]; SCIENTIST [184.16 h]; ELEC DES [214.86 h]; ELEC ENG [153.47 h]; ELEC TECH [61.39 h]; MECH DES [184.16 h] | 93,670.68 | ELOUADRHIRI L | 1 | 1 |  | LATIFA E |  | 11-026 |  |  |  |  |  |  |  |  |  |  |  |  |  | 4 | APP |  | 4211 | 09-049 | 11 -035 | 13-002F |  |  |  |  |  | 11-001 |  |  |  |  |  |  |  |
| 14211015 |  | Torus Vend Compnts Fab Original Labor FY10 |  | 188d | 2010-01-05 | 2010-09-30 | 14211004, 14211004B, 9-100M FS+60d | 749d | 0d |  | ELEC DES [61.39 h]; ELEC ENG [61.39 h]; ELEC TECH [46.04 h]; MECH DES [122.78 h]; MECH ENG [214.86 h]; MECH TECH [306.94 h]; SCIENTIST [92.08 h]; SKLLD TRADE [36.83 h] | 48,666.82 | ELOUADRHIRI L | 1 | 1 |  | LATIFA E |  | 11-026 |  |  |  |  |  |  |  |  |  |  |  |  |  | 4 | APP |  | 4211 | 09-049 | 11 -035 | 13-002F |  |  |  |  |  | 11-001 |  |  |  |  |  |  |  |
| 14211040A |  | Vend Fab Torus - Superconductor Production Reverse Entry per CR10-044 |  | 1d | 2010-03-01 | 2010-03-01 | 9-100M FS+97d | 1200d | 0d |  | PROCUREMENT>$50K 69 NO ESCALATION | -262,000 | ELOUADRHIRI L | 1 | 1 |  | LATIFA E |  | 11-026 |  |  |  |  |  |  |  |  |  |  |  |  |  |  | APP |  | 4211 |  | 11 -035 | 13-002F | 12-024F |  | 10-044 |  |  |  |  |  |  |  |  |  |  |
| 14211040B |  | Vend Fab Torus - Superconductor Production Revised Delivery per CR10-044 |  | 172d | 2010-03-01 | 2010-10-29 | 9-100M FS+97d | 1155d | 0d |  | PROCUREMENT>$50K 69 NO ESCALATION | 262,000 | ELOUADRHIRI L | 1 | 1 |  | LATIFA E |  | 11-026 |  |  |  |  |  |  |  |  |  |  |  |  |  |  | APP |  | 4211 |  | 11 -035 | 13-002F | 12-024F |  | 10-044 |  |  |  |  |  |  |  |  |  |  |
| 14211045A |  | Vend Fab Torus - Completion of Preliminary Design Review and Manufacturing Readiness Review Reverse Entry per CR10-044 |  | 1d | 2010-03-01 | 2010-03-01 | 9-100M FS+97d | 1200d | 0d |  | PROCUREMENT>$50K 69 NO ESCALATION | -324,000 | ELOUADRHIRI L | 1 | 1 |  | LATIFA E |  | 11-026 | IN |  |  |  |  |  |  |  |  |  |  |  |  |  | APP |  | 4211 |  | 11 -035 | 13-002F | 12-024F |  | 10-044 |  |  |  |  |  |  |  |  |  |  |
| 14211045B |  | Vend Fab Torus - Completion of IDR Revised Delivery per CR10-044 |  | 172d | 2010-03-01 | 2010-10-29 | 9-100M FS+97d | 1236d | 0d |  | PROCUREMENT>$50K 69 NO ESCALATION | 108,000 | ELOUADRHIRI L | 1 | 1 |  | LATIFA E |  | 11-026 | IN |  |  |  |  |  |  |  |  |  |  |  |  |  | APP |  | 4211 |  | 11 -035 | 13-002F | 12-024F |  | 10-044 |  | SC |  |  |  |  |  |  |  |  |
| 14211045C |  | Vend Fab Torus - Completion of FDR Revised Delivery per CR10-044 |  | 229d | 2010-03-01 | 2011-01-31 | 9-100M FS+97d, 14211045B FS-172d | 1236d | 0d |  | PROCUREMENT>$50K 69 NO ESCALATION | 108,000 | ELOUADRHIRI L | 1 | 1 |  | LATIFA E |  | 11-026 | IN |  |  |  |  |  |  |  |  |  |  |  |  |  | APP |  | 4211 |  | 11 -035 | 13-002F | 12-024F |  | 10-044 |  | SC |  |  |  |  |  |  |  |  |
| 14211045D |  | Vend Fab Torus - Completion Manufacturing Readiness ReviewRevised Delivery per CR10-044 |  | 229d | 2010-03-01 | 2011-01-31 | 9-100M FS+97d, 14211045C FS-229d | 1236d | 36d |  | PROCUREMENT>$50K 69 NO ESCALATION | 108,000 | ELOUADRHIRI L | 1 | 1 |  | LATIFA E |  | 11-026 | IN |  |  |  |  |  |  |  |  |  |  |  |  |  | APP |  | 4211 |  | 11 -035 | 13-002F | 12-024F |  | 10-044 |  | SC |  |  |  |  |  |  |  |  |
| 14211010a |  | Torus Vend Coil Winding Original Labor FY11 |  | 57d | 2010-10-01 | 2010-12-29 | 14211010 | 749d | 3d |  | MECH TECH [232.65 h]; SCIENTIST [55.84 h]; ELEC DES [65.14 h]; ELEC ENG [46.53 h]; ELEC TECH [18.61 h]; MECH DES [55.84 h]; MECH ENG [83.76 h] | 29,305.74 | ELOUADRHIRI L | 1 | 1 |  | LATIFA E |  | 11-026 |  |  |  |  |  |  |  |  |  |  |  |  |  | 4 | APP |  | 4211 | 09-049 | 11 -035 | 13-002F |  |  |  |  |  | 11-001 |  |  |  |  |  |  |  |
| 14211011E |  | Torus FY11 Travel |  | 248d | 2010-10-01 | 2011-09-30 | 14211010E | 0d |  |  | TRAVEL | 8,503.77 | ELOUADRHIRI L | 1 | 1 |  | LATIFA E |  |  |  |  |  |  |  |  |  |  |  |  |  | 07-024 |  |  |  |  |  |  |  |  |  |  |  |  |  |  |  |  |  |  |  |  |  |
| 14211015a |  | Torus Vend Compnts Fab Original Labor FY11 |  | 57d | 2010-10-01 | 2010-12-29 | 14211015 | 749d | 3d |  | MECH ENG [65.14 h]; MECH TECH [93.06 h]; SCIENTIST [27.92 h]; SKLLD TRADE [11.17 h]; ELEC DES [18.61 h]; ELEC ENG [18.61 h]; ELEC TECH [13.96 h]; MECH DES [37.22 h] | 15,225.06 | ELOUADRHIRI L | 1 | 1 |  | LATIFA E |  | 11-026 |  |  |  |  |  |  |  |  |  |  |  |  |  | 4 | APP |  | 4211 | 09-049 | 11 -035 | 13-002F |  |  |  |  |  | 11-001 |  |  |  |  |  |  |  |
| 14211050AdA |  | Vend Fab Torus - Coil Case Plates-Mill run Phase 3 Funding |  | 99d | 2010-11-01 | 2011-03-31 | 14211050Ad FS-99d | 1319d | 0d |  | PROCUREMENT>$50K 69 NO ESCALATION | 22,799 | ELOUADRHIRI L | 1 | 1 |  | LATIFA E |  | 11-026 | IN |  |  |  |  |  |  |  |  |  |  |  |  |  | APP |  | 4211 |  | 11 -035 | 13-002F | 12-024F |  | 10-044 | 11-023 | SC |  |  |  |  |  |  |  |  |
| 14211051 |  | Vend Fab Torus - Coil Case Plates-CNC machining |  | 206d | 2010-11-01 | 2011-08-31 | 14211050AdA FS-99d | 1319d | 0d |  | PROCUREMENT>$50K 69 NO ESCALATION | 56,225 | ELOUADRHIRI L | 1 | 1 |  | LATIFA E |  | 11-026 | IN |  |  |  |  |  |  |  |  |  |  |  |  |  | APP |  | 4211 |  | 11 -035 | 13-002F | 12-024F |  | 10-044 | 11-023 | SC |  |  |  |  |  |  |  |  |
| 14211051a |  | Vend Fab Torus - He tracing Tube - OFHC |  | 206d | 2010-11-01 | 2011-08-31 | 14211051 FS-206d | 1319d | 0d |  | PROCUREMENT>$50K 69 NO ESCALATION | 16,291 | ELOUADRHIRI L | 1 | 1 |  | LATIFA E |  | 11-026 | IN |  |  |  |  |  |  |  |  |  |  |  |  |  | APP |  | 4211 |  | 11 -035 | 13-002F | 12-024F |  | 10-044 | 11-023 | SC |  |  |  |  |  |  |  |  |
| 14211051b |  | Vend Fab Torus - Torus Vac Vessel Plate-Mill run |  | 206d | 2010-11-01 | 2011-08-31 | 14211051a FS-206d | 1319d | 0d |  | PROCUREMENT>$50K 69 NO ESCALATION | 125,000 | ELOUADRHIRI L | 1 | 1 |  | LATIFA E |  | 11-026 | IN |  |  |  |  |  |  |  |  |  |  |  |  |  | APP |  | 4211 |  | 11 -035 | 13-002F | 12-024F |  | 10-044 | 11-023 | SC |  |  |  |  |  |  |  |  |
| 14211051c |  | Vend Fab Torus - Nitrogen tracing tube |  | 206d | 2010-11-01 | 2011-08-31 | 14211051b FS-206d | 1319d | 0d |  | PROCUREMENT>$50K 69 NO ESCALATION | 7,425 | ELOUADRHIRI L | 1 | 1 |  | LATIFA E |  | 11-026 | IN |  |  |  |  |  |  |  |  |  |  |  |  |  | APP |  | 4211 |  | 11 -035 | 13-002F | 12-024F |  | 10-044 | 11-023 | SC |  |  |  |  |  |  |  |  |
| 14211051d |  | Vend Fab Torus - Torus Vac Vessel Plate-CNC machining |  | 206d | 2010-11-01 | 2011-08-31 | 14211051c FS-206d | 1319d | 0d |  | PROCUREMENT>$50K 69 NO ESCALATION | 100,000 | ELOUADRHIRI L | 1 | 1 |  | LATIFA E |  | 11-026 | IN |  |  |  |  |  |  |  |  |  |  |  |  |  | APP |  | 4211 |  | 11 -035 | 13-002F | 12-024F |  | 10-044 | 11-023 | SC |  |  |  |  |  |  |  |  |
| 14211051f |  | Vend Fab Torus - Torus Coil Hub&Machining |  | 206d | 2010-11-01 | 2011-08-31 | 14211051d FS-206d | 1319d | 0d |  | PROCUREMENT>$50K 69 NO ESCALATION | 12,260 | ELOUADRHIRI L | 1 | 1 |  | LATIFA E |  | 11-026 | IN |  |  |  |  |  |  |  |  |  |  |  |  |  | APP |  | 4211 |  | 11 -035 | 13-002F | 12-024F |  | 10-044 | 11-023 | SC |  |  |  |  |  |  |  |  |
| 14211051g |  | Vend Fab Torus - Cryogenic Control Valves |  | 206d | 2010-11-01 | 2011-08-31 | 14211051f FS-206d | 1319d | 0d |  | PROCUREMENT>$50K 69 NO ESCALATION | 40,000 | ELOUADRHIRI L | 1 | 1 |  | LATIFA E |  | 11-026 | IN |  |  |  |  |  |  |  |  |  |  |  |  |  | APP |  | 4211 |  | 11 -035 | 13-002F | 12-024F |  | 10-044 | 11-023 | SC |  |  |  |  |  |  |  |  |
| 14211051h |  | Vend Fab Torus - Current Leads |  | 206d | 2010-11-01 | 2011-08-31 | 14211051g FS-206d | 1319d | 0d |  | PROCUREMENT>$50K 69 NO ESCALATION | 30,000 | ELOUADRHIRI L | 1 | 1 |  | LATIFA E |  | 11-026 | IN |  |  |  |  |  |  |  |  |  |  |  |  |  | APP |  | 4211 |  | 11 -035 | 13-002F | 12-024F |  | 10-044 | 11-023 | SC |  |  |  |  |  |  |  |  |
| 14211051j |  | Vend Fab Torus - Instrumentation Sensors |  | 206d | 2010-11-01 | 2011-08-31 | 14211051h FS-206d | 1319d | 0d |  | PROCUREMENT>$50K 69 NO ESCALATION | 50,000 | ELOUADRHIRI L | 1 | 1 |  | LATIFA E |  | 11-026 | IN |  |  |  |  |  |  |  |  |  |  |  |  |  | APP |  | 4211 |  | 11 -035 | 13-002F | 12-024F |  | 10-044 | 11-023 | SC |  |  |  |  |  |  |  |  |
| 14211051k |  | Vend Fab Torus - Dump Switch |  | 206d | 2010-11-01 | 2011-08-31 | 14211051j FS-206d | 1319d | 0d |  | PROCUREMENT>$50K 69 NO ESCALATION | 50,000 | ELOUADRHIRI L | 1 | 1 |  | LATIFA E |  | 11-026 | IN |  |  |  |  |  |  |  |  |  |  |  |  |  | APP |  | 4211 |  | 11 -035 | 13-002F | 12-024F |  | 10-044 | 11-023 | SC |  |  |  |  |  |  |  |  |
| 14211051n |  | Vend Fab Torus - PLC&Cabinets |  | 206d | 2010-11-01 | 2011-08-31 | 14211051k FS-206d | 1319d | 0d |  | PROCUREMENT>$50K 69 NO ESCALATION | 12,000 | ELOUADRHIRI L | 1 | 1 |  | LATIFA E |  | 11-026 | IN |  |  |  |  |  |  |  |  |  |  |  |  |  | APP |  | 4211 |  | 11 -035 | 13-002F | 12-024F |  | 10-044 | 11-023 | SC |  |  |  |  |  |  |  |  |
| 14211051o |  | Vend Fab Torus - Cold Mass Suspension Materials |  | 206d | 2010-11-01 | 2011-08-31 | 14211051n FS-206d | 1319d | 1316d |  | PROCUREMENT>$50K 69 NO ESCALATION | 50,000 | ELOUADRHIRI L | 1 | 1 |  | LATIFA E |  | 11-026 | IN |  |  |  |  |  |  |  |  |  |  |  |  |  | APP |  | 4211 |  | 11 -035 | 13-002F | 12-024F |  | 10-044 | 11-023 | SC |  |  |  |  |  |  |  |  |
| 14211065 |  | Vend Fab Torus -Complete and Warm Test Coil #3 |  | 325d | 2010-11-01 | 2012-02-29 | 14211060 FS-325d | 1200d | 0d |  | PROCUREMENT>$50K 69 NO ESCALATION; PROCUREMENT<$50K 60 NO ESCALATION | 235,000 | ELOUADRHIRI L | 1 | 1 |  | LATIFA E |  | 11-026 | IN |  |  |  |  |  |  |  |  |  |  |  |  |  | APP |  | 4211 | 09-049 | 11 -035 | 13-002F | 12-024 |  | 10-044 | 11-023 | SC |  |  |  |  |  |  |  |  |
| 14211070 |  | Vend Fab Torus -Complete and Warm Test Coil #4 |  | 325d | 2010-11-01 | 2012-02-29 | 14211065 FS-325d | 1200d | 0d |  | PROCUREMENT>$50K 69 NO ESCALATION | 235,000 | ELOUADRHIRI L | 1 | 1 |  | LATIFA E |  | 11-026 | IN |  |  |  |  |  |  |  |  |  |  |  |  |  | APP |  | 4211 | 09-049 | 11 -035 | 13-002F | 12-024 |  | 10-044 | 11-023 | SC |  |  |  |  |  |  |  |  |
| 14211075 |  | Vend Fab Torus -Complete and Warm Test Coil #5 |  | 325d | 2010-11-01 | 2012-02-29 | 14211070 FS-325d | 1200d | 0d |  | PROCUREMENT>$50K 69 NO ESCALATION | 235,000 | ELOUADRHIRI L | 1 | 1 |  | LATIFA E |  | 11-026 | IN |  |  |  |  |  |  |  |  |  |  |  |  |  | APP |  | 4211 | 09-049 | 11 -035 | 13-002F | 12-024 |  | 10-044 | 11-023 | SC |  |  |  |  |  |  |  |  |
| 14211080 |  | Vend Fab Torus -Complete and Warm Test Coil #6 |  | 325d | 2010-11-01 | 2012-02-29 | 14211075 FS-325d | 1200d | 1197d |  | PROCUREMENT>$50K 69 NO ESCALATION | 235,000 | ELOUADRHIRI L | 1 | 1 |  | LATIFA E |  | 11-026 | IN |  |  |  |  |  |  |  |  |  |  |  |  |  | APP |  | 4211 | 09-049 | 11 -035 | 13-002F | 12-024 |  | 10-044 | 11-023 | SC |  |  |  |  |  |  |  |  |
| 14211020 |  | Torus Vend Contract Support Labor FY11 |  | 188d | 2011-01-05 | 2011-09-30 | 9-110M FS+60d, 14211010a, 14211015a | 746d | 0d |  | SKLLD TRADE [36.83 h]; MECH DES [122.78 h]; ELEC DES [61.39 h]; ELEC ENG [61.39 h]; ELEC TECH [46.04 h]; MECH ENG [245.55 h]; MECH TECH [306.94 h]; SCIENTIST [92.08 h] | 52,303.48 | ELOUADRHIRI L | 1 | 1 |  | LATIFA E |  | 11-026 |  |  |  |  |  |  |  |  |  |  |  |  |  | 4 | APP |  | 4211 | 09-049 | 11 -035 | 13-002F |  |  |  |  |  |  | 12-001 |  |  |  |  |  |  |
| 14211012E |  | Torus FY12 Travel |  | 247d | 2011-10-03 | 2012-09-28 | 14211011E | 0d |  |  | TRAVEL | 8,775.04 | ELOUADRHIRI L | 1 | 1 |  | LATIFA E |  |  |  |  |  |  |  |  |  |  |  |  |  | 07-024 |  |  |  |  |  |  |  |  |  |  |  |  |  |  |  |  |  |  |  |  |  |
| 14211020a |  | Torus Vend Contract Support Labor FY12 |  | 57d | 2011-10-03 | 2011-12-29 | 14211020 | 746d | 3d |  | ELEC DES [18.61 h]; ELEC ENG [18.61 h]; ELEC TECH [13.96 h]; MECH DES [37.22 h]; MECH ENG [74.45 h]; MECH TECH [93.06 h]; SCIENTIST [27.92 h]; SKLLD TRADE [11.17 h] | 16,363.14 | ELOUADRHIRI L | 1 | 1 |  | LATIFA E |  | 11-026 |  |  |  |  |  |  |  |  |  |  |  |  |  | 4 | APP |  | 4211 | 09-049 | 11 -035 | 13-002F |  |  |  |  |  |  | 12-001 |  |  |  |  |  |  |
| 14211025 |  | Torus Delivery Installtn & Check-out Original Labor FY12 |  | 187d | 2012-01-05 | 2012-09-28 | 14211020a, 9-120M FS+60d | 743d | 0d |  | ELEC DES [152.65 h]; ELEC ENG [30.53 h]; ELEC TECH [30.53 h]; MECH DES [122.12 h]; MECH ENG [244.24 h]; MECH TECH [457.96 h]; SCIENTIST [30.53 h]; SKLLD TRADE [48.85 h]; MSHOP | 162,381.52 | ELOUADRHIRI L | 1 | 1 |  | LATIFA E |  | 11-026 |  |  |  |  |  |  |  |  |  |  |  |  |  | 4 | APP |  | 4211 | 09-049 | 11 -035 | 13-002F |  |  |  |  |  |  |  | 12-053 |  |  |  |  |  |
| 14211085 |  | Reverse Entry per CR12-024 |  | 18d | 2012-02-03 | 2012-02-29 | 9-120M FS+80d | 149d |  |  | PROCUREMENT<$50K 60 NO ESCALATION; PROCUREMENT>$50K 69 NO ESCALATION | -1,847,553 | ELOUADRHIRI L | 1 | 1 |  | LATIFA E |  | 11-026 | IN |  |  |  |  |  |  |  |  |  |  |  |  |  | APP |  | 4211 | 09-049 | 11 -035 |  | 12-024 |  | 10-044 |  | SC |  |  |  |  |  |  |  |  |
| 14211025a |  | Torus Delivery Installtn & Check-out Original Labor FY13 |  | 58d | 2012-10-01 | 2012-12-21 | 14211025 | 743d | 740d |  | ELEC TECH [9.47 h]; MECH DES [37.88 h]; MECH ENG [75.76 h]; MECH TECH [142.04 h]; SCIENTIST [9.47 h]; SKLLD TRADE [15.15 h]; MSHOP; ELEC DES [47.35 h]; ELEC ENG [9.47 h] | 51,972.48 | ELOUADRHIRI L | 1 | 1 |  | LATIFA E |  | 11-026 |  |  |  |  |  |  |  |  |  |  |  |  |  | 4 | APP |  | 4211 | 09-049 | 11 -035 | 13-002F |  |  |  |  |  |  |  | 12-053 |  |  |  |  |  |
| 14211095 |  | Re-Baseline Actuals Adjustment |  | 1d | 2013-08-30 | 2013-08-30 | 9-130M FS+227d | 20d |  |  | PROCUREMENT>$50K 69 NO ESCALATION | 512,279.26 | ELOUADRHIRI L | 1 | 1 |  | LATIFA E |  |  |  |  |  |  | 13-014 | ADJ |  |  |  |  |  |  |  |  |  |  |  |  |  |  |  |  |  |  |  |  |  |  |  |  |  |  |  |
| 24211090 |  | Wang Torus Settlement |  | 20d | 2013-09-03 | 2013-09-30 | 9-130M FS+228d | 801d | 798d | 8/5 M-F w/JLAB Holidays ReBaseline | PROCUREMENT<$50K 60 NO ESCALATION; PROCUREMENT>$50K 69 NO ESCALATION | 217,517.76 | ELOUADRHIRI L | 1 | 1 |  | LATIFA E |  | 11-026 | IN |  |  |  |  |  |  | 24211090 |  | 13-015 | PR |  |  |  | APP |  | 4211 | 09-049 | 11 -035 | 13-002F | 12-024 |  | 10-044 |  | SC |  |  |  | y | 12-055 | OB | OB |  |
| 24211095 |  | Wang Torus Settlement Final |  | 20d | 2013-09-03 | 2013-09-30 | 9-130M FS+228d | 801d | 798d | 8/5 M-F w/JLAB Holidays ReBaseline | PROCUREMENT<$50K 60 NO ESCALATION; PROCUREMENT>$50K 69 NO ESCALATION | 421,264.48 | ELOUADRHIRI L | 1 | 1 |  | LATIFA E |  | 11-026 | IN |  |  |  |  |  |  | 24211090 |  | 13-015 | PR |  |  |  | APP |  | 4211 | 09-049 | 11 -035 | 13-002F | 12-024 |  | 10-044 |  | SC |  |  |  |  | 12-055 | OB |  | 13-016 |

Notes:
- 14211040C: Steps: OFHC Stabilizer; Soldering line development; Solder stabiizer test run
- 14211050A: Steps: Proto test; Proto Cryostat Assembly
- 14211040B: Steps: OFHC Stabilizer; Soldering line development; Solder stabiizer test run
- 14211045D: Steps: MRR Phase1 -Demo Proto winding; MRR Phase2 - After Proto test

| ID | WBS | Activity | Duration | Start | Finish | Predecessors | Total float | Free float | Calendar | Resources | Cost | RESP - Responsibility | STRT%COMP for CM EVM | FNSH%COMP for CM EVM | CR 07-024 | CAM RESPONSIBLE | CR 08-058 | CR 11-005 | CR 11-026 | CR 11-035 | Advance Purchase Plan > 500K | CR 08-016 | 12 GEV MAJOR PROCUREMENT CATAGORY | CR 09-012 | CR 10-001 | CR 10-005 | CR 11-022 | CR 12-024 | CR 13-002 | CR 10-044 | Schedule Contingency | CR 11-022a | CR 08-052 | CR 11-001 | CR 08-039 | CR 12-001 | CR 13-014 | ReBaseline Actuals Adjustment | Original Activity ID Rebaseline | Over Under Fixed | CR 12-055 | BOE Procurement | CR 13-015 | Post Rebaseline | Obligated Prior to Rebaseline | PHAS - Project Phase | CR 09-049 | CR 13-016 |
| --- | --- | --- | --- | --- | --- | --- | --- | --- | --- | --- | --- | --- | --- | --- | --- | --- | --- | --- | --- | --- | --- | --- | --- | --- | --- | --- | --- | --- | --- | --- | --- | --- | --- | --- | --- | --- | --- | --- | --- | --- | --- | --- | --- | --- | --- | --- | --- | --- |
|  | 2 | **1.4.2.1.2 SOLENOID** |  | 2009-01-02 | 2013-09-30 |  |  |  |  |  |  |  |  |  |  |  |  |  |  |  |  |  |  |  |  |  |  |  |  |  |  |  |  |  |  |  |  |  |  |  |  |  |  |  |  |  |  |  |
| 14212009E |  | Solenoid FY09 Travel | 189d | 2009-01-02 | 2009-09-30 | 14212009EX | 19d | 0d |  | TRAVEL | 6,086.21 | ELOUADRHIRI L | 1 | 1 | 07-024 | LATIFA E | 08-058 | 11-005 | 11-026 | 11 -035 |  |  |  |  |  |  |  |  |  |  |  |  |  |  |  |  |  |  |  |  |  |  |  |  |  |  |  |  |
| 14212005 |  | Solenoid Vend Comp Dsgn Labor FY09 | 188d | 2009-01-05 | 2009-09-30 | 14212002X FS+1d | 19d | 0d |  | MECH ENG [61.39 h]; ELEC TECH [15.35 h]; MECH TECH [245.55 h]; ELEC ENG [15.35 h]; MECH DES [61.39 h]; VISTNG USERS [92.08 h]; SCIENTIST [15.35 h]; OFFICE [30.69 h] | 21,547.09 | ELOUADRHIRI L | 1 | 1 |  | LATIFA E |  | 11-005 | 11-026 | 11 -035 | APP | 08-016 | 4212 | 09-012 | 10-001B |  |  |  |  |  |  |  |  |  |  |  |  |  |  |  |  |  |  |  |  |  |  |  |
| 14212005b |  | Solenoid Vend Comp Dsgn Labor FY10 | 57d | 2009-10-01 | 2009-12-29 | 14212005 | 19d | 0d |  | ELEC ENG [4.65 h]; MECH DES [18.61 h]; VISTNG USERS [27.92 h]; SCIENTIST [4.65 h]; OFFICE [9.31 h]; MECH ENG [18.61 h]; ELEC TECH [4.65 h]; MECH TECH [74.45 h] | 6,740.52 | ELOUADRHIRI L | 1 | 1 |  | LATIFA E |  | 11-005 | 11-026 | 11 -035 | APP |  | 4212 |  | 10-001B |  |  |  |  |  |  |  |  |  |  |  |  |  |  |  |  |  |  |  |  |  |  |  |
| 14212010E |  | Solenoid FY10 Travel | 248d | 2009-10-01 | 2010-09-30 | 14212009E | 19d | 0d |  | TRAVEL | 8,240.89 | ELOUADRHIRI L | 1 | 1 | 07-024 | LATIFA E |  | 11-005 | 11-026 | 11 -035 |  |  |  |  |  |  |  |  |  |  |  |  |  |  |  |  |  |  |  |  |  |  |  |  |  |  |  |  |
| 14212005c |  | Vend Fab Solenoid Peg Point #1 Completion of System Requirements Review (SSR) | 22d | 2009-11-20 | 2009-12-30 | 14212002X FS+1d, 9-100M FS+36d | 1200d | 0d |  | PROCUREMENT>$50K 69 NO ESCALATION; PROCUREMENT<$50K 60 NO ESCALATION | 100,000 | ELOUADRHIRI L | 1 | 1 |  | LATIFA E |  |  | 11-026 | 11 -035 | APP |  | 4212 |  | 10-001B | 10-005 | 11-022 | 12-024F | 13-002F |  |  |  |  |  |  |  |  |  |  |  |  |  |  |  |  |  |  |  |
| 14212005d |  | Vend Fab Solenoid Peg Point #2 Completion of Preliminary Design Review | 61d | 2009-11-20 | 2010-02-26 | 14212005c FS-22d | 1200d | 0d |  | PROCUREMENT>$50K 69 NO ESCALATION | 100,000 | ELOUADRHIRI L | 1 | 1 |  | LATIFA E |  |  | 11-026 | 11 -035 | APP |  | 4212 |  |  | 10-005 | 11-022 | 12-024F | 13-002F |  |  |  |  |  |  |  |  |  |  |  |  |  |  |  |  |  |  |  |
| 14212005f |  | Vend Fab Solenoid Peg Point #3 Design, Construction and Testing of Prototype Testcoil | 253d | 2009-11-20 | 2010-11-30 | 14212005dB FS-193d, 14212005dA FS-62d, 14212005d FS-61d | 1200d | 0d |  | PROCUREMENT>$50K 69 NO ESCALATION | 200,000 | ELOUADRHIRI L | 1 | 1 |  | LATIFA E |  |  | 11-026 | 11 -035 | APP |  | 4212 |  |  | 10-005 | 11-022 | 12-024F | 13-002F | 10-044 | SC |  |  |  |  |  |  |  |  |  |  |  |  |  |  |  |  |  |
| 14212005g |  | Vend Fab Solenoid Peg Point #4 Intermediate Design Review | 270d | 2009-11-20 | 2010-12-30 | 14212005f FS-253d | 1200d | 0d |  | PROCUREMENT>$50K 69 NO ESCALATION | 200,000 | ELOUADRHIRI L | 1 | 1 |  | LATIFA E |  |  | 11-026 | 11 -035 | APP |  | 4212 |  |  | 10-005 | 11-022 | 12-024F | 13-002F | 10-044 | SC |  |  |  |  |  |  |  |  |  |  |  |  |  |  |  |  |  |
| 14212005h |  | Vend Fab Solenoid Peg Point #5 Final Design Review | 309d | 2009-11-20 | 2011-02-28 | 14212005g FS-270d | 1200d | 0d |  | PROCUREMENT>$50K 69 NO ESCALATION | 200,000 | ELOUADRHIRI L | 1 | 1 |  | LATIFA E |  |  | 11-026 | 11 -035 | APP |  | 4212 |  |  | 10-005 | 11-022 | 12-024F | 13-002F | 10-044 | SC |  |  |  |  |  |  |  |  |  |  |  |  |  |  |  |  |  |
| 14212005j |  | Vend Fab Solenoid Peg Point #6A Manufacturing Readiness Review Phase 1 | 373d | 2009-11-20 | 2011-05-27 | 14212005h FS-309d | 1200d | 0d |  | PROCUREMENT>$50K 69 NO ESCALATION | 25,000 | ELOUADRHIRI L | 1 | 1 |  | LATIFA E |  |  | 11-026 | 11 -035 | APP |  | 4212 |  |  | 10-005 | 11-022 | 12-024F | 13-002F | 10-044 | SC |  |  |  |  |  |  |  |  |  |  |  |  |  |  |  |  |  |
| 14212005jA |  | Vend Fab Solenoid Peg Point #6B Manufacturing Readiness Review Phase 2 | 416d | 2009-11-20 | 2011-07-29 | 14212005j FS-373d | 1200d | 0d |  | PROCUREMENT>$50K 69 NO ESCALATION | 25,000 | ELOUADRHIRI L | 1 | 1 |  | LATIFA E |  |  | 11-026 | 11 -035 | APP |  | 4212 |  |  | 10-005 | 11-022 | 12-024F | 13-002F | 10-044 | SC |  |  |  |  |  |  |  |  |  |  |  |  |  |  |  |  |  |
| 14212005k |  | Vend Fab Solenoid Peg Point #7 Complete Winding & Coil Assembly of First set coils (1 to 6 modules) | 557d | 2009-11-20 | 2012-02-28 | 14212005jA FS-416d | 1200d | 0d |  | PROCUREMENT>$50K 69 NO ESCALATION | 50,000 | ELOUADRHIRI L | 1 | 1 |  | LATIFA E |  |  | 11-026 | 11 -035 | APP |  | 4212 |  |  | 10-005 | 11-022 | 12-024F | 13-002F | 10-044 | SC |  |  |  |  |  |  |  |  |  |  |  |  |  |  |  |  |  |
| 14212005kA |  | Vend Fab Solenoid Peg Point #18 Miscellaneous Materials Procurements Phase 1 | 501d | 2009-11-20 | 2011-11-30 | 14212005k FS-557d | 1200d | 0d |  | PROCUREMENT>$50K 69 NO ESCALATION | 100,000 | ELOUADRHIRI L | 1 | 1 |  | LATIFA E |  |  | 11-026 | 11 -035 | APP |  | 4212 |  |  | 10-005 | 11-022 | 12-024F | 13-002F | 10-044 | SC | 11-022a |  |  |  |  |  |  |  |  |  |  |  |  |  |  |  |  |
| 14212007 |  | Solenoid Vend Comp Dsgn & Prcrmnt Original Labor FY10 | 191d | 2009-12-30 | 2010-09-30 | 14212005b, 9-100M | 19d | 0d |  | MECH TECH [246.45 h]; VISTNG USERS [92.42 h]; SCIENTIST [15.4 h]; OFFICE [30.81 h]; ELEC ENG [15.4 h]; ELEC TECH [15.4 h]; MECH ENG [61.61 h]; MECH DES [61.61 h] | 22,314.58 | ELOUADRHIRI L | 1 | 1 |  | LATIFA E |  | 11-005 | 11-026 | 11 -035 | APP |  | 4212 | 09-012 |  | 10-005 |  |  |  |  |  |  | 08-052 | 11-001 |  |  |  |  |  |  |  |  |  |  |  |  |  |  |
| 14212005dA |  | Vend Fab Solenoid Peg Point #2 Completion of Preliminary Design Review Reverse Entry per CR10-044 | 1d | 2010-03-01 | 2010-03-01 | 9-100M FS+97d | 1200d | 0d |  | PROCUREMENT>$50K 69 NO ESCALATION | -100,000 | ELOUADRHIRI L | 1 | 1 |  | LATIFA E |  |  | 11-026 | 11 -035 | APP |  | 4212 |  |  |  | 11-022 | 12-024F | 13-002F | 10-044 |  |  |  |  |  |  |  |  |  |  |  |  |  |  |  |  |  |  |
| 14212005dB |  | Vend Fab Solenoid Peg Point #2 Completion of Preliminary Design Review Revised Delivery per CR10-044 | 130d | 2010-03-01 | 2010-08-31 | 9-100M FS+97d | 1202d | 2d |  | PROCUREMENT>$50K 69 NO ESCALATION | 100,000 | ELOUADRHIRI L | 1 | 1 |  | LATIFA E |  |  | 11-026 | 11 -035 | APP |  | 4212 |  |  |  | 11-022 | 12-024F | 13-002F | 10-044 | SC |  |  |  |  |  |  |  |  |  |  |  |  |  |  |  |  |  |
| 14212007a |  | Solenoid Vend Comp Dsgn & Prcrmnt Original Labor FY11 | 57d | 2010-10-01 | 2010-12-29 | 14212007 | 19d | 0d |  | ELEC TECH [4.6 h]; MECH ENG [18.39 h]; MECH DES [18.39 h]; MECH TECH [73.55 h]; VISTNG USERS [27.58 h]; SCIENTIST [4.6 h]; OFFICE [9.19 h]; ELEC ENG [4.6 h] | 6,872.78 | ELOUADRHIRI L | 1 | 1 |  | LATIFA E |  | 11-005 | 11-026 | 11 -035 | APP |  | 4212 | 09-012 |  | 10-005 |  |  |  |  |  |  | 08-052 | 11-001 |  |  |  |  |  |  |  |  |  |  |  |  |  |  |
| 14212011E |  | Solenoid FY11 Travel | 248d | 2010-10-01 | 2011-09-30 | 14212010E | 19d | 0d |  | TRAVEL | 8,503.77 | ELOUADRHIRI L | 1 | 1 | 07-024 | LATIFA E |  | 11-005 | 11-026 | 11 -035 |  |  |  |  |  |  |  |  |  |  |  |  |  |  |  |  |  |  |  |  |  |  |  |  |  |  |  |  |
| 14212010 |  | Solenoid Vend Coil Winding Original Labor FY11 | 191d | 2010-12-30 | 2011-09-30 | 14212007a | 19d | 0d |  | ELEC ENG [30.81 h]; MECH TECH [308.06 h]; SCIENTIST [46.21 h]; MECH DES [92.42 h]; MECH ENG [92.42 h]; VISTNG USERS [92.42 h] | 30,862.22 | ELOUADRHIRI L | 1 | 1 |  | LATIFA E |  | 11-005 | 11-026 | 11 -035 | APP |  | 4212 | 09-012 |  | 10-005 |  |  |  |  |  |  | 08-052 |  | 08-039 | 12-001 |  |  |  |  |  |  |  |  |  |  |  |  |
| 14212015 |  | Solenoid Vend Compnts Fab Original Labor FY11 | 191d | 2010-12-30 | 2011-09-30 | 14212007a | 19d | 0d |  | VISTNG USERS [92.42 h]; MECH TECH [308.06 h]; ELEC ENG [15.4 h]; MECH DES [61.61 h]; ELEC TECH [15.4 h]; SCIENTIST [15.4 h]; MECH ENG [61.61 h] | 24,827.05 | ELOUADRHIRI L | 1 | 1 |  | LATIFA E |  | 11-005 | 11-026 | 11 -035 | APP |  | 4212 | 09-012 |  | 10-005 |  |  |  |  |  |  | 08-052 |  |  | 12-001 |  |  |  |  |  |  |  |  |  |  |  |  |
| 14212005kA5 |  | Vend Fab Solenoid Peg Point #18a Miscellaneous Materials Procurements Phase 2 | 211d | 2011-02-01 | 2011-11-30 | 14212005kA FS-211d | 1200d | 0d |  | PROCUREMENT<$50K 60 NO ESCALATION; PROCUREMENT>$50K 69 NO ESCALATION | 452,210 | ELOUADRHIRI L | 1 | 1 |  | LATIFA E |  |  | 11-026 | 11 -035 | APP |  | 4212 |  |  | 10-005 | 11-022 | 12-024F | 13-002F | 10-044 | SC | 11-022a |  |  |  |  |  |  |  |  |  |  |  |  |  |  |  |  |
| 14212005n |  | Vend Fab Solenoid Peg Point #8 Mid-Term Manufacturing Progress Review | 268d | 2011-02-01 | 2012-02-29 | 14212005kA5 FS-211d | 1200d | 0d |  | PROCUREMENT>$50K 69 NO ESCALATION | 48,790 | ELOUADRHIRI L | 1 | 1 |  | LATIFA E |  |  | 11-026 | 11 -035 | APP |  | 4212 |  |  | 10-005 | 11-022 | 12-024 | 13-002F | 10-044 | SC |  |  |  |  |  |  |  |  |  |  |  |  |  |  |  |  |  |
| 14212005o |  | Vend Fab Solenoid Peg Point #9 Complete Winding & Coil Assembly of Second set coils (7 to 12 modules) | 268d | 2011-02-01 | 2012-02-29 | 14212005n FS-268d | 1200d | 0d |  | PROCUREMENT>$50K 69 NO ESCALATION | 50,000 | ELOUADRHIRI L | 1 | 1 |  | LATIFA E |  |  | 11-026 | 11 -035 | APP |  | 4212 |  |  | 10-005 | 11-022 | 12-024 | 13-002F | 10-044 | SC |  |  |  |  |  |  |  |  |  |  |  |  |  |  |  |  |  |
| 14212005p |  | Vend Fab Solenoid Peg Point #10 Complete Winding & Coil Assembly of Third set coils (13 to 19 modules) | 268d | 2011-02-01 | 2012-02-29 | 14212005o FS-268d | 1200d | 0d |  | PROCUREMENT>$50K 69 NO ESCALATION | 50,000 | ELOUADRHIRI L | 1 | 1 |  | LATIFA E |  |  | 11-026 | 11 -035 | APP |  | 4212 |  |  | 10-005 | 11-022 | 12-024 | 13-002F | 10-044 | SC |  |  |  |  |  |  |  |  |  |  |  |  |  |  |  |  |  |
| 14212005q |  | Vend Fab Solenoid Peg Point #11 Complete Instrumentation and Control | 268d | 2011-02-01 | 2012-02-29 | 14212005p FS-268d | 1200d | 0d |  | PROCUREMENT>$50K 69 NO ESCALATION | 80,000 | ELOUADRHIRI L | 1 | 1 |  | LATIFA E |  |  | 11-026 | 11 -035 | APP |  | 4212 |  |  | 10-005 | 11-022 | 12-024 | 13-002F | 10-044 | SC |  |  |  |  |  |  |  |  |  |  |  |  |  |  |  |  |  |
| 14212005r |  | Vend Fab Solenoid Peg Point #12 Complete Subcontractor Acceptance Test Readiness Review | 268d | 2011-02-01 | 2012-02-29 | 14212005q FS-268d | 1200d | 0d |  | PROCUREMENT>$50K 69 NO ESCALATION | 50,000 | ELOUADRHIRI L | 1 | 1 |  | LATIFA E |  |  | 11-026 | 11 -035 | APP |  | 4212 |  |  | 10-005 | 11-022 | 12-024 | 13-002F | 10-044 | SC |  |  |  |  |  |  |  |  |  |  |  |  |  |  |  |  |  |
| 14212005s |  | Vend Fab Solenoid Peg Point #13 Complete Cryogenic Reservoir Subassembly Phase 1 | 268d | 2011-02-01 | 2012-02-29 | 14212005r FS-268d | 1200d | 1197d |  | PROCUREMENT>$50K 69 NO ESCALATION | 69,000 | ELOUADRHIRI L | 1 | 1 |  | LATIFA E |  |  | 11-026 | 11 -035 | APP |  | 4212 |  |  | 10-005 | 11-022 | 12-024 | 13-002F | 10-044 | SC |  |  |  |  |  |  |  |  |  |  |  |  |  |  |  |  |  |
| 14212010a |  | Solenoid Vend Coil Winding Original Labor FY12 | 57d | 2011-10-03 | 2011-12-29 | 14212010 | 19d | 0d |  | ELEC ENG [9.19 h]; MECH TECH [91.94 h]; SCIENTIST [13.79 h]; MECH DES [27.58 h]; MECH ENG [27.58 h]; VISTNG USERS [27.58 h] | 9,503.53 | ELOUADRHIRI L | 1 | 1 |  | LATIFA E |  | 11-005 | 11-026 | 11 -035 | APP |  | 4212 | 09-012 |  | 10-005 |  |  |  |  |  |  | 08-052 |  | 08-039 | 12-001 |  |  |  |  |  |  |  |  |  |  |  |  |
| 14212012E |  | Solenoid FY12 Travel | 228d | 2011-10-03 | 2012-08-31 | 14212011E | 19d |  |  | TRAVEL | 8,775.04 | ELOUADRHIRI L | 1 | 1 | 07-024 | LATIFA E |  | 11-005 | 11-026 | 11 -035 |  |  |  |  |  | 10-005 |  |  |  |  |  |  |  |  |  |  |  |  |  |  |  |  |  |  |  |  |  |  |
| 14212015a |  | Solenoid Vend Compnts Fab Original Labor FY12 | 57d | 2011-10-03 | 2011-12-29 | 14212015 | 19d | 0d |  | MECH TECH [91.94 h]; ELEC ENG [4.6 h]; MECH DES [18.39 h]; ELEC TECH [4.6 h]; SCIENTIST [4.6 h]; MECH ENG [18.39 h]; VISTNG USERS [27.58 h] | 7,646.68 | ELOUADRHIRI L | 1 | 1 |  | LATIFA E |  | 11-005 | 11-026 | 11 -035 | APP |  | 4212 | 09-012 |  | 10-005 |  |  |  |  |  |  | 08-052 |  |  | 12-001 |  |  |  |  |  |  |  |  |  |  |  |  |
| 14212020 |  | Solenoid Vend Assy & Testing Original Labor | 61d | 2011-11-23 | 2012-02-29 | 9-120M FS+22d, 14212015a FS-20d, 14212010a FS-20d | 19d | 0d |  | MECH TECH [480 h]; ELEC ENG [20 h]; VISTNG USERS [120 h]; MECH DES [120 h]; SCIENTIST [40 h]; MECH ENG [120 h]; ELEC TECH [40 h] | 43,846.4 | ELOUADRHIRI L | 1 | 1 |  | LATIFA E |  | 11-005 | 11-026 | 11 -035 | APP |  | 4212 | 09-012 |  | 10-005 |  |  |  |  |  |  | 08-052 |  |  |  |  |  |  |  |  |  |  |  |  |  |  |  |
| 14212005sA |  | Reverse Entry per CR12-024 | 18d | 2012-02-03 | 2012-02-29 | 9-120M FS+80d | 149d |  |  | PROCUREMENT<$50K 60 NO ESCALATION; PROCUREMENT>$50K 69 NO ESCALATION | -808,277.32 | ELOUADRHIRI L | 1 | 1 |  | LATIFA E |  |  | 11-026 | 11 -035 | APP |  | 4212 |  |  | 10-005 | 11-022 | 12-024 |  | 10-044 | SC |  |  |  |  |  |  |  |  |  |  |  |  |  |  |  |  |  |
| 14212025 |  | Solenoid Delivery & Qualification Check-out Original Labor | 130d | 2012-03-01 | 2012-08-31 | 14212020 | 19d |  |  | ELEC TECH [40 h]; MSHOP; VISTNG USERS [120 h]; MECH ENG [120 h]; MECH DES [120 h]; MECH TECH [480 h]; ELEC ENG [20 h] | 74,460.77 | ELOUADRHIRI L | 1 | 1 |  | LATIFA E |  | 11-005 | 11-026 | 11 -035 | APP | 08-016 | 4212 | 09-012 |  | 10-005 |  |  |  |  |  |  | 08-052 |  |  |  |  |  |  |  |  |  |  |  |  |  |  |  |
| 14212030 |  | Re-Baseline Actuals Adjustment | 1d | 2013-08-30 | 2013-08-30 | 9-130M FS+227d | 20d |  |  | PROCUREMENT>$50K 69 NO ESCALATION | 307,509.11 | ELOUADRHIRI L | 1 | 1 |  | LATIFA E |  |  |  |  |  |  |  |  |  |  |  |  |  |  |  |  |  |  |  |  | 13-014 | ADJ |  |  |  |  |  |  |  |  |  |  |
| 24212000 |  | Wang Solenoid Settlement | 20d | 2013-09-03 | 2013-09-30 | 9-130M FS+228d | 801d | 798d | 8/5 M-F w/JLAB Holidays ReBaseline | PROCUREMENT<$50K 60 NO ESCALATION; PROCUREMENT>$50K 69 NO ESCALATION | 36,924.5 | ELOUADRHIRI L | 1 | 1 |  | LATIFA E |  |  | 11-026 | 11 -035 | APP |  | 4212 |  |  | 10-005 | 11-022 | 12-024 | 13-002F | 10-044 | SC |  |  |  |  |  |  |  | 24212005t | y | 12-055 | OB | 13-015 | PR | OB |  |  |  |
| 24212005 |  | Wang Solenoid Settlement Final | 20d | 2013-09-03 | 2013-09-30 | 9-130M FS+228d | 801d | 798d | 8/5 M-F w/JLAB Holidays ReBaseline | PROCUREMENT<$50K 60 NO ESCALATION; PROCUREMENT>$50K 69 NO ESCALATION | 286,075.5 | ELOUADRHIRI L | 1 | 1 |  | LATIFA E |  |  | 11-026 | 11 -035 | APP |  | 4211 |  |  |  |  | 12-024 | 13-002F | 10-044 | SC |  |  |  |  |  |  |  | 24211090 |  | 12-055 | OB | 13-015 | PR |  | IN | 09-049 | 13-016 |

Notes:
- 14212005f: Steps: Proto Cond Soldering; Proto Coil Winding; Proto Coil Assy & Test; Solenoid Vac Vessel Plate-Mill run Step from 14212005kA; Cryogenic Control Valves Step from 14212005kA; Instrumentation Sensors Step from 14212005kA
- 14212005kA: Steps: Steps moved from 14212005kA5
- 14212005kA5: Steps: OFHC Stabilizer; Coil Caser Plate-Mill run; Coil Case Plates-CNC machining; Epoxy; Solenoid Vac Vessel Plate-Mill run $ reside in 14212005f; Solenoid Vac Vessel Plate-CNC machining; Cryogenic Control Valves $ reside in 14212005f; Current Leads; Instrumentation Sensors $ reside in 14212005f; Dump Switch; PLC&Cabinets; Cold Mass Suspension Materials

| ID | WBS | Activity | Type | Duration | Start | Finish | Predecessors | Total float | Free float | Resources | Cost | RESP - Responsibility | STRT%COMP for CM EVM | FNSH%COMP for CM EVM | CR 07-024 | CAM RESPONSIBLE | CR 11-005 | CR 11-026 | CR 11-035 | CR 12-013 | Advance Purchase Plan > 500K | CR 08-016 | 12 GEV MAJOR PROCUREMENT CATAGORY | CR 09-012 | CR 11-001 | CR 13-002 | CR 10-060 | CR 11-013 | Profile change | CR 11-024 | Pat's Code | SVT | CR 11-058 | CR 12-054 | CR 12-001 | CR 12-027 | CR 12-053 |
| --- | --- | --- | --- | --- | --- | --- | --- | --- | --- | --- | --- | --- | --- | --- | --- | --- | --- | --- | --- | --- | --- | --- | --- | --- | --- | --- | --- | --- | --- | --- | --- | --- | --- | --- | --- | --- | --- |
|  | 2 | **1.4.2.2 DETECTORS** |  |  | 2008-10-01 | 2015-08-04 |  |  |  |  |  |  |  |  |  |  |  |  |  |  |  |  |  |  |  |  |  |  |  |  |  |  |  |  |  |  |  |
|  | 1 | **1.4.2.2.1 TRACKING** |  |  | 2008-10-01 | 2015-04-01 |  |  |  |  |  |  |  |  |  |  |  |  |  |  |  |  |  |  |  |  |  |  |  |  |  |  |  |  |  |  |  |
|  | 1 | **1.4.2.2.1.1 SILICON DETECTOR** |  |  | 2009-10-01 | 2014-12-12 |  |  |  |  |  |  |  |  |  |  |  |  |  |  |  |  |  |  |  |  |  |  |  |  |  |  |  |  |  |  |  |
| 142211010E |  | SVT-FY10 Travel |  | 248d | 2009-10-01 | 2010-09-30 | 9-100M | 20d | 0d | TRAVEL | 4,395.14 | ELOUADRHIRI L | 1 | 1 | 07-024 | LATIFA E | 11-005 | 11-026 | 11 -035 | 12-013 |  |  |  |  |  |  |  |  |  |  |  |  |  |  |  |  |  |
| 142211005 |  | SVT-P-#1 Daq Production, Silicon Sensor Assys Labor FY10 |  | 226d | 2009-11-02 | 2010-09-30 | 12222015M, 9-100M FS+22d, 12222000a | 539d | 0d | ELEC TECH [568.23 h]; COMP SCIENT [180.8 h]; MECH ENG [90.4 h]; MSHOP; MECH TECH [180.8 h]; MECH DES [90.4 h]; CONTRB UNIV LBR [2272.91 h]; PD UNIV STAFF [258.29 h]; SCIENTIST [126.56 h]; ELEC ENG [154.97 h]; ELEC DES [284.11 h]; VISTNG USERS [568.23 h] | 116,057.71 | ELOUADRHIRI L | 1 | 1 |  | LATIFA E | 11-005 | 11-026 | 11 -035 | 12-013 | APP | 08-016 | 42211 | 09-012 | 11-001 | 13-002F |  |  |  |  |  |  |  |  |  |  |  |
| 142211004 |  | SVT Assembly Area & Clean Room |  | 163d | 2010-08-02 | 2011-03-31 | 9-100M FS+205d | 543d | 4d | PROCUREMENT>$50K 69 NO ESCALATION FY11; PROCUREMENT<$50K 60 NO ESCALATION FY11 | 120,000 | ELOUADRHIRI L | 1 | 1 |  | LATIFA E | 11-005 | 11-026 | 11 -035 | 12-013 |  |  |  |  |  | 13-002F | 10-060 |  |  |  |  |  |  |  |  |  |  |
| 142211005a |  | SVT-P-#1 Daq Production, Silicon Sensor Assys Labor FY11 |  | 124d | 2010-10-01 | 2011-04-06 | 12222015M, 12222000a, 9-100M FS+22d, 142211005 | 539d | 0d | ELEC ENG [85.03 h]; ELEC TECH [311.77 h]; COMP SCIENT [99.2 h]; MECH ENG [49.6 h]; MSHOP; MECH TECH [99.2 h]; ELEC DES [155.89 h]; VISTNG USERS [311.77 h]; MECH DES [49.6 h]; CONTRB UNIV LBR [1247.09 h]; PD UNIV STAFF [141.71 h]; SCIENTIST [69.44 h] | 65,707.68 | ELOUADRHIRI L | 1 | 1 |  | LATIFA E | 11-005 | 11-026 | 11 -035 | 12-013 | APP | 08-016 | 42211 | 09-012 | 11-001 | 13-002F |  |  |  |  |  |  |  |  |  |  |  |
| 142211011E |  | SVT-FY11 Travel |  | 248d | 2010-10-01 | 2011-09-30 | 142211010E | 20d | 0d | TRAVEL | 4,535.34 | ELOUADRHIRI L | 1 | 1 | 07-024 | LATIFA E | 11-005 | 11-026 | 11 -035 | 12-013 |  |  |  |  |  |  |  |  |  |  |  |  |  |  |  |  |  |
| 142211005b |  | Vend Fab SVT Barrel Sensors Layers 1-3 Peg Point #1 NRE for Hybrid Mask |  | 33d | 2010-12-07 | 2011-01-31 | 12222015M, 9-110M FS+45d, 12222000a | 20d | 0d | PROCUREMENT<$50K 60 NO ESCALATION; PROCUREMENT>$50K 69 NO ESCALATION | 51,800 | ELOUADRHIRI L | 1 | 1 |  | LATIFA E | 11-005 | 11-026 | 11 -035 | 12-013 | APP | 08-016 | 42211 | 09-012 | 11-001 | 13-002F |  | 11-013 |  |  |  |  |  |  |  |  |  |
| 142211005c |  | Vend Fab SVT Barrel Sensors Layers 1-3 Peg Point #2 NRE for Intermediate Mask |  | 33d | 2010-12-07 | 2011-01-31 | 142211005b FS-33d | 20d | 0d | PROCUREMENT>$50K 69 NO ESCALATION | 51,800 | ELOUADRHIRI L | 1 | 1 |  | LATIFA E | 11-005 | 11-026 | 11 -035 | 12-013 | APP | 08-016 | 42211 | 09-012 | 11-001 | 13-002F |  | 11-013 |  |  |  |  |  |  |  |  |  |
| 142211005d |  | Vend Fab SVT Barrel Sensors Layers 1-3 Peg Point #3 NRE for FAR Mask |  | 33d | 2010-12-07 | 2011-01-31 | 142211005c FS-33d | 20d | 0d | PROCUREMENT>$50K 69 NO ESCALATION | 51,800 | ELOUADRHIRI L | 1 | 1 |  | LATIFA E | 11-005 | 11-026 | 11 -035 | 12-013 | APP | 08-016 | 42211 | 09-012 | 11-001 | 13-002F |  | 11-013 |  |  |  |  |  |  |  |  |  |
| 142211005f |  | Vend Fab SVT Barrel Sensors Layers 1-3 Peg Point #4 NRE for Mask Redesign |  | 33d | 2010-12-07 | 2011-01-31 | 142211005d FS-33d | 20d | 0d | PROCUREMENT>$50K 69 NO ESCALATION | 43,500 | ELOUADRHIRI L | 1 | 1 |  | LATIFA E | 11-005 | 11-026 | 11 -035 | 12-013 | APP | 08-016 | 42211 | 09-012 | 11-001 | 13-002F |  | 11-013 |  |  |  |  |  |  |  |  |  |
| 142211005g |  | Vend Fab SVT Barrel Sensors Layers 1-3 Peg Point #5 Hybrid Wafers Qty 3 |  | 117d | 2010-12-07 | 2011-05-31 | 142211005f FS-33d | 20d | 0d | PROCUREMENT>$50K 69 NO ESCALATION | 22,872 | ELOUADRHIRI L | 1 | 1 |  | LATIFA E | 11-005 | 11-026 | 11 -035 | 12-013 | APP | 08-016 | 42211 | 09-012 | 11-001 | 13-002F |  | 11-013 |  |  |  |  |  |  |  |  |  |
| 142211005h |  | Vend Fab SVT Barrel Sensors Layers 1-3 Peg Point #6 Intermediate Wafers Qty 3 |  | 117d | 2010-12-07 | 2011-05-31 | 142211005g FS-117d | 20d | 0d | PROCUREMENT>$50K 69 NO ESCALATION | 22,872 | ELOUADRHIRI L | 1 | 1 |  | LATIFA E | 11-005 | 11-026 | 11 -035 | 12-013 | APP | 08-016 | 42211 | 09-012 | 11-001 | 13-002F |  | 11-013 |  |  |  |  |  |  |  |  |  |
| 142211005j |  | Vend Fab SVT Barrel Sensors Layers 1-3 Peg Point #7 FAR Wafers Qty 3 |  | 117d | 2010-12-07 | 2011-05-31 | 142211005h FS-117d | 20d | 0d | PROCUREMENT>$50K 69 NO ESCALATION | 22,872 | ELOUADRHIRI L | 1 | 1 |  | LATIFA E | 11-005 | 11-026 | 11 -035 | 12-013 | APP | 08-016 | 42211 | 09-012 | 11-001 | 13-002F |  | 11-013 |  |  |  |  |  |  |  |  |  |
| 142211005k |  | Vend Fab SVT Barrel Sensors Layers 1-3 Peg Point #8 Hybrid Sensors Qty 120 |  | 431d | 2010-12-07 | 2012-08-31 | 142211005j FS-117d | 20d | 0d | PROCUREMENT>$50K 69 NO ESCALATION | 156,600 | ELOUADRHIRI L | 1 | 1 |  | LATIFA E | 11-005 | 11-026 | 11 -035 | 12-013 | APP | 08-016 | 42211 | 09-012 | 11-001 | 13-002F |  | 11-013 |  |  |  |  |  |  |  |  |  |
| 142211005n |  | Vend Fab SVT Barrel Sensors Layers 1-3 Peg Point #9 Intermediate Sensors Qty 120 |  | 431d | 2010-12-07 | 2012-08-31 | 142211005k FS-431d | 187d | 0d | PROCUREMENT>$50K 69 NO ESCALATION | 156,600 | ELOUADRHIRI L | 1 | 1 |  | LATIFA E | 11-005 | 11-026 | 11 -035 | 12-013 | APP | 08-016 | 42211 | 09-012 | 11-001 | 13-002F |  | 11-013 |  |  |  |  |  |  |  |  |  |
| 142211005p |  | Vend Fab SVT Barrel Sensors Layers 1-3 Peg Point #7 FAR Sensors Qty 120 |  | 431d | 2010-12-07 | 2012-08-31 | 142211005n FS-431d | 187d | 59d | PROCUREMENT>$50K 69 NO ESCALATION | 156,600 | ELOUADRHIRI L | 1 | 1 |  | LATIFA E | 11-005 | 11-026 | 11 -035 | 12-013 | APP | 08-016 | 42211 | 09-012 | 11-001 | 13-002F |  | 11-013 |  |  |  |  |  |  |  |  |  |
| 142211020 |  | SVT-Production R1, R2, R3 Stave Barrel & Wedge Assy (Frozen by CR11-005) |  | 120d | 2011-02-09 | 2011-07-29 | 142211005a FS-40d, 142211005b FS-40d, 9-110M FS+63d, 142211005 FS-40d | 539d |  | PD UNIV STAFF [96 h]; MECH TECH [64 h]; MECH ENG [16 h]; COMP SCIENT [32 h]; ELEC ENG [64 h]; ELEC TECH [234.67 h]; CONTRB UNIV LBR [469.2 h]; MECH DES [16 h]; SCIENTIST [26.67 h]; VISTNG USERS [234.67 h]; ELEC DES [117.33 h] | 38,229.5 | ELOUADRHIRI L | 1 | 1 |  | LATIFA E | 11-005 | 11-026 | 11 -035 | 12-013 | APP | 08-016 |  | 09-012 |  | 13-002F |  |  | C |  |  |  |  |  |  |  |  |
| 142211004a |  | Room Preperation and Finishes EEL230 |  | 23d | 2011-03-01 | 2011-03-31 | 9-110M FS+97d | 148d | 128d | PROCUREMENT<$50K 60 | 50,000 | ELOUADRHIRI L | 1 | 1 |  | LATIFA E | 11-005 |  | 11 -035 |  |  |  |  |  |  |  |  |  |  | 11-024 |  |  |  |  |  |  |  |
| 142211105 |  | SVT Clean Room Purchase |  | 107d | 2011-03-01 | 2011-07-29 | 9-110M FS+97d | 539d | 0d | PROCUREMENT<$50K 60; PROCUREMENT>$50K 69 | 302,000 | ELOUADRHIRI L | 1 | 1 |  | LATIFA E | 11-005 |  | 11 -035 | 12-013 |  |  |  |  |  | 13-002F |  |  |  | 11-024 |  |  |  |  |  |  |  |
| 142211105a |  | SVT Clean Room Electrical |  | 107d | 2011-03-01 | 2011-07-29 | 142211105 FS-107d | 539d | 0d | PROCUREMENT<$50K 60 | 60,000 | ELOUADRHIRI L | 1 | 1 |  | LATIFA E | 11-005 |  | 11 -035 | 12-013 |  |  |  |  |  | 13-002F |  |  |  | 11-024 |  |  |  |  |  |  |  |
| 142211105b |  | SVT Clean Room Data/Comm |  | 107d | 2011-03-01 | 2011-07-29 | 142211105a FS-107d | 539d | 0d | PROCUREMENT<$50K 60 | 10,000 | ELOUADRHIRI L | 1 | 1 |  | LATIFA E | 11-005 |  | 11 -035 | 12-013 |  |  |  |  |  | 13-002F |  |  |  | 11-024 |  |  |  |  |  |  |  |
| 142211105c |  | SVT Clean Room Demo/Interior Finishes |  | 107d | 2011-03-01 | 2011-07-29 | 142211105b FS-107d | 539d | 0d | PROCUREMENT<$50K 60 | 20,000 | ELOUADRHIRI L | 1 | 1 |  | LATIFA E | 11-005 |  | 11 -035 | 12-013 |  |  |  |  |  | 13-002F |  |  |  | 11-024 |  |  |  |  |  |  |  |
| 142211105d |  | SVT Clean Room Mechanicals |  | 107d | 2011-03-01 | 2011-07-29 | 142211105c FS-107d | 539d | 0d | PROCUREMENT<$50K 60 | 66,000 | ELOUADRHIRI L | 1 | 1 |  | LATIFA E | 11-005 |  | 11 -035 | 12-013 |  |  |  |  |  | 13-002F |  |  |  | 11-024 |  |  |  |  |  |  |  |
| 142211105f |  | SVT Clean Room Sprinklers |  | 107d | 2011-03-01 | 2011-07-29 | 142211105d FS-107d | 539d | 0d | PROCUREMENT<$50K 60 | 5,000 | ELOUADRHIRI L | 1 | 1 |  | LATIFA E | 11-005 |  | 11 -035 | 12-013 |  |  |  |  |  | 13-002F |  |  |  | 11-024 |  |  |  |  |  |  |  |
| 142211105g |  | SVT Clean Room Moving Expenses |  | 107d | 2011-03-01 | 2011-07-29 | 142211105f FS-107d | 539d | 0d | PROCUREMENT<$50K 60 | 5,500 | ELOUADRHIRI L | 1 | 1 |  | LATIFA E | 11-005 |  | 11 -035 | 12-013 |  |  |  |  |  | 13-002F |  |  |  | 11-024 |  |  |  |  |  |  |  |
| 142211105h |  | SVT Clean Room Furniture |  | 107d | 2011-03-01 | 2011-07-29 | 142211105g FS-107d | 539d |  | PROCUREMENT<$50K 60 | 30,000 | ELOUADRHIRI L | 1 | 1 |  | LATIFA E | 11-005 |  | 11 -035 | 12-013 |  |  |  |  |  | 13-002F |  |  |  | 11-024 |  |  |  |  |  |  |  |
| 142211010 |  | SVT-P-#2 Daq Production, Silicon Sensor Assys (Frozen by CR11-005) |  | 80d | 2011-04-07 | 2011-07-29 | 142211005, 142211005a, 142211005b, 142211004 | 539d |  | ELEC TECH [352 h]; MECH ENG [56 h]; MECH DES [56 h]; ELEC DES [176 h]; VISTNG USERS [352 h]; COMP SCIENT [112 h]; SCIENTIST [24 h]; PD UNIV STAFF [160 h]; MSHOP; CONTRB UNIV LBR [1408 h]; MECH TECH [112 h]; ELEC ENG [96 h] | 70,227.68 | ELOUADRHIRI L | 1 | 1 |  | LATIFA E | 11-005 | 11-026 | 11 -035 | 12-013 | APP | 08-016 | 42211 | 09-012 |  | 13-002F |  | 11-013 | C |  |  |  |  |  |  |  |  |
| 142211010a |  | Reverse Entry per CR11-005 |  | 5d | 2011-08-01 | 2011-08-05 | 9-110M FS+204d | 39d |  | VISTNG USERS [-352 h]; COMP SCIENT [-112 h]; SCIENTIST [-24 h]; PD UNIV STAFF [-160 h]; MSHOP; MECH TECH [-112 h]; ELEC ENG [-96 h]; ELEC TECH [-352 h]; MECH ENG [-56 h]; MECH DES [-56 h]; ELEC DES [-176 h] | -70,227.68 | ELOUADRHIRI L | 1 | 1 |  | LATIFA E | 11-005 | 11-026 | 11 -035 | 12-013 | APP | 08-016 | 42211 | 09-012 |  |  |  | 11-013 | C |  |  |  |  |  |  |  |  |
| 142211020a |  | Reverse Entry per CR11-005 |  | 5d | 2011-08-01 | 2011-08-05 | 9-110M FS+204d | 39d |  | ELEC DES [-117.33 h]; COMP SCIENT [-32 h]; PD UNIV STAFF [-96 h]; MECH TECH [-64 h]; MECH ENG [-16 h]; ELEC ENG [-64 h]; ELEC TECH [-234.67 h]; MECH DES [-16 h]; SCIENTIST [-26.67 h]; VISTNG USERS [-234.67 h] | -38,229.5 | ELOUADRHIRI L | 1 | 1 |  | LATIFA E | 11-005 | 11-026 | 11 -035 | 12-013 | APP | 08-016 |  | 09-012 |  |  |  |  | C |  |  |  |  |  |  |  |  |
| 142211109M |  | HBI - 2011 Replan - Milestone | milestone | 0d | 2011-08-01 | 2011-08-01 | 9-110M FS+204d | 20d | 0d |  |  | ELOUADRHIRI L | 1 | 1 |  | LATIFA E | 11-005 |  |  | 12-013 |  |  |  |  |  | 13-002F |  |  |  |  | Pat | HBI | 11-058 | 12-054F |  |  |  |
| 142211110 |  | BST R1-R3 Collab-MSU - Contract award for full chain test, 1st article - Proc |  | 371d | 2011-08-01 | 2013-01-31 | 142211109M | 168d |  | PROCUREMENT>$50K 69 NO ESCALATION FY12; PROCUREMENT<$50K 60 NO ESCALATION FY12 | 97,940 | ELOUADRHIRI L | 1 | 1 |  | LATIFA E | 11-005 |  |  | 12-013 |  |  |  |  |  | 13-002F |  |  |  |  | Pat |  |  |  |  |  |  |
| 142211120 |  | HBI - SVT Engineering and Construction Oversight FY11 |  | 44d | 2011-08-01 | 2011-09-30 | 142211109M | 20d | 0d | SCIENTIST [264 h] | 18,065.52 | ELOUADRHIRI L | 1 | 1 |  | LATIFA E | 11-005 |  |  |  |  |  |  |  |  |  |  |  |  |  | Pat | HBI |  |  | 12-001 |  |  |
| 142211140 |  | BST R1-R3 HBI - 1 ASIC: ASIC production: testing, and dicing - Proc |  | 128d | 2011-08-01 | 2012-02-08 | 142211109M | 197d | 160d | PROCUREMENT<$50K 60 NO ESCALATION FY12; PROCUREMENT>$50K 69 NO ESCALATION FY12 | 81,164 | ELOUADRHIRI L | 1 | 1 |  | LATIFA E | 11-005 |  |  | 12-013 |  |  |  |  |  | 13-002F |  |  |  |  | Pat | HBI | 11-058 | 12-054F |  |  |  |
| 142211145 |  | BST R1-R3 HBI - 2 Sensors: Sensors received and inspected by JLab (1st article and production) - Labor FY11 |  | 44d | 2011-08-01 | 2011-09-30 | 142211005j FS+42d, 142211005h, 142211005g | 21d | 0d | ELEC TECH [67.26 h]; SCIENTIST [33.63 h]; ELEC ENG [67.26 h] | 9,777.25 | ELOUADRHIRI L | 1 | 1 |  | LATIFA E | 11-005 |  |  | 12-013 |  |  |  |  |  | 13-002F |  |  |  |  | Pat | HBI | 11-058 |  | 12-001 | 12-027F |  |
| 142211155 |  | BST FNAL - Contract Preparations |  | 43d | 2011-08-01 | 2011-09-29 | 142211109M | 21d | 0d | ELEC ENG [160 h]; SCIENTIST [160 h] | 21,889.6 | ELOUADRHIRI L | 1 | 1 |  | LATIFA E | 11-005 |  |  | 12-013 |  |  |  |  |  | 13-002F |  |  |  |  | Pat |  | 11-058 |  |  | 12-027F |  |
| 142211165 |  | BST R1-R3 HBI - 3: Modules: DAq development front end electronics (1st article) - Labor FY11 |  | 44d | 2011-08-01 | 2011-09-30 | 142211109M | 20d | 0d | ELEC ENG [170.87 h]; SCIENTIST [170.87 h] | 23,376.72 | ELOUADRHIRI L | 1 | 1 |  | LATIFA E | 11-005 |  |  | 12-013 |  |  |  |  |  | 13-002F |  |  |  |  | Pat | HBI | 11-058 |  | 12-001 |  |  |
| 142211170 |  | BST R1-R3 HBI - 4: DAq: 1st article software - Labor FY11 |  | 44d | 2011-08-01 | 2011-09-30 | 142211109M | 20d | 0d | SCIENTIST [129.41 h]; ELEC ENG [129.41 h] | 17,704.59 | ELOUADRHIRI L | 1 | 1 |  | LATIFA E | 11-005 |  |  | 12-013 |  |  |  |  |  | 13-002F |  |  |  |  | Pat | HBI | 11-058 |  | 12-001 |  |  |
| 142211185 |  | BST R1-R3 HBI - 5 Electronics: Pitch Adapter - Proc (Full set for 1st article, R1-R3, R4) |  | 128d | 2011-08-01 | 2012-02-08 | 142211109M | 411d |  | PROCUREMENT<$50K 60 NO ESCALATION FY12 | 21,683 | ELOUADRHIRI L | 1 | 1 |  | LATIFA E | 11-005 |  |  | 12-013 |  |  |  |  |  | 13-002F |  |  |  |  | Pat | HBI | 11-058 |  |  |  |  |
| 142211190 |  | BST R1-R3 HBI - 5 Electronics: HFCB validation tests (1st article) - Proc |  | 128d | 2011-08-01 | 2012-02-08 | 142211109M | 197d | 0d | PROCUREMENT<$50K 60 NO ESCALATION FY12 | 18,543 | ELOUADRHIRI L | 1 | 1 |  | LATIFA E | 11-005 |  |  | 12-013 |  |  |  |  |  | 13-002F |  |  |  |  | Pat | HBI | 11-058 | 12-054F |  |  |  |
| 142211195 |  | BST R1-R3 HBI - 6: Cable assemblies: HV, LV, and data (1) specifications and procurement prep - Labor FY11 |  | 44d | 2011-08-01 | 2011-09-30 | 142211109M | 251d | 0d | ELEC ENG [29.83 h]; MECH TECH [29.83 h] | 3,324.56 | ELOUADRHIRI L | 1 | 1 |  | LATIFA E | 11-005 |  |  |  |  |  |  |  |  | 13-002F |  |  |  |  | Pat | HBI | 11-058 |  | 12-001 |  |  |
| 142211215 |  | BST R1-R3 HBI - 7 Sloco: HV, LV, PS (1) module components and crates specs and procurement prep - Labor FY11 |  | 44d | 2011-08-01 | 2011-09-30 | 142211109M | 83d | 0d | ELEC ENG [13.75 h]; MECH TECH [13.75 h] | 1,532.44 | ELOUADRHIRI L | 1 | 1 |  | LATIFA E | 11-005 |  |  | 12-013 |  |  |  |  |  | 13-002F |  |  |  |  | Pat | HBI | 11-058 | 12-054F | 12-001 |  |  |
| 142211235 |  | BST R1-R3 HBI - 8 DAq: VME: (1) specification and procurement preparation - Labor |  | 23d | 2011-08-01 | 2011-08-31 | 142211109M | 297d | 0d | MECH TECH [40 h]; ELEC ENG [40 h] | 4,458 | ELOUADRHIRI L | 1 | 1 |  | LATIFA E | 11-005 |  |  | 12-013 |  |  |  |  |  | 13-002F |  |  |  |  | Pat | HBI | 11-058 | 12-054F |  |  |  |
| 142211280 |  | BST R1-R3 MECH GRP - Modules: 1st article backing structure manufacturing drawing - Labor |  | 42d | 2011-08-01 | 2011-09-28 | 142211109M | 421d | 184d | MECH ENG [320 h]; MECH DES [320 h]; ELEC ENG [160 h] | 47,622.4 | ELOUADRHIRI L | 1 | 1 |  | LATIFA E | 11-005 |  |  | 12-013 |  |  |  |  |  | 13-002F |  |  |  |  | Pat | MECH | 11-058 | 12-054F |  | 12-027F |  |
| 142211285 |  | BST R1-R3 MECH GRP - Modules: 1st article cold plate manufacturing drawing - Labor FY11 |  | 44d | 2011-08-01 | 2011-09-30 | 142211109M | 226d | 0d | MECH DES [125.71 h]; ELEC ENG [83.81 h]; MECH ENG [125.71 h] | 20,141.06 | ELOUADRHIRI L | 1 | 1 |  | LATIFA E | 11-005 |  |  | 12-013 |  |  |  |  |  | 13-002F |  |  |  |  | Pat | MECH | 11-058 | 12-054F | 12-001 |  |  |
| 142211305 |  | BST R1-R3 MECH GRP - Support structure for cold plate 1st article tests: Manufacturing Drawings - Labor |  | 30d | 2011-08-01 | 2011-09-12 | 142211109M | 286d | 0d | MECH DES [80 h]; MECH ENG [80 h] | 9,170.4 | ELOUADRHIRI L | 1 | 1 |  | LATIFA E | 11-005 |  |  | 12-013 |  |  |  |  |  | 13-002F |  |  |  |  | Pat | MECH | 11-058 | 12-054F |  |  |  |
| 142211150 |  | BST R1-R3 HBI - 2 Sensors: Sensors shipped to FNAL (1st article) |  | 21d | 2011-08-05 | 2011-09-02 | 142211145aa FS-310d, 142211005j | 21d | 0d | MECH TECH [80 h] | 3,445.6 | ELOUADRHIRI L | 1 | 1 |  | LATIFA E | 11-005 |  |  | 12-013 |  |  |  |  |  | 13-002F |  |  |  |  | Pat | HBI | 11-058 |  |  | 12-027F |  |
| 142211115 |  | HBI - Hardware infrastructure: configuring and installing- Labor FY11 |  | 23d | 2011-08-30 | 2011-09-30 | 142211109M FS+21d | 411d | 0d | ELEC TECH [34.39 h] | 1,470.86 | ELOUADRHIRI L | 1 | 1 |  | LATIFA E | 11-005 |  |  |  |  |  |  |  |  | 13-002F |  |  |  |  | Pat | HBI |  |  | 12-001 |  |  |
| 142211158M |  | BST FNAL - 1st article & production SOW Agreement signed (milestone) | milestone | 0d | 2011-09-01 | 2011-09-01 | 9-110M FS+227d | 21d | 0d |  |  | ELOUADRHIRI L | 1 | 1 |  | LATIFA E | 11-005 |  |  | 12-013 |  |  |  |  |  | 13-002F |  |  |  |  | Pat |  | 11-058 |  |  | 12-027F |  |
| 142211160 |  | FNAL/Jlab/MSU Testing of 1st article sensors |  | 79d | 2011-09-01 | 2011-12-30 | 142211158M, 142211155 FS-20d | 21d | 0d | PROCUREMENT<$50K 60 NO ESCALATION | 5,495 | ELOUADRHIRI L | 1 | 1 |  | LATIFA E | 11-005 |  |  | 12-013 |  |  |  |  |  | 13-002F |  |  |  |  | Pat |  | 11-058 |  |  | 12-027F |  |
| 142211160a |  | FNAL Module Design Review |  | 42d | 2011-09-01 | 2011-10-31 | 142211160 FS-79d | 21d | 0d | PROCUREMENT<$50K 60 NO ESCALATION | 5,495 | ELOUADRHIRI L | 1 | 1 |  | LATIFA E | 11-005 |  |  | 12-013 |  |  |  |  |  | 13-002F |  |  |  |  | Pat |  | 11-058 |  |  | 12-027F |  |
| 142211160b |  | FNAL Module Design Report & Recommendations |  | 42d | 2011-09-01 | 2011-10-31 | 142211160a FS-42d | 21d | 0d | PROCUREMENT<$50K 60 NO ESCALATION | 5,495 | ELOUADRHIRI L | 1 | 1 |  | LATIFA E | 11-005 |  |  | 12-013 |  |  |  |  |  | 13-002F |  |  |  |  | Pat |  | 11-058 |  |  | 12-027F |  |
| 142211160c |  | FNAL/Jlab Develop Module Construction, Assembly, & QA/QC procedures |  | 62d | 2011-09-01 | 2011-11-30 | 142211160b FS-42d | 21d | 0d | PROCUREMENT<$50K 60 NO ESCALATION | 8,702 | ELOUADRHIRI L | 1 | 1 |  | LATIFA E | 11-005 |  |  | 12-013 |  |  |  |  |  | 13-002F |  |  |  |  | Pat |  | 11-058 |  |  | 12-027F |  |
| 142211160d |  | FNAL Construction & Testing (FNAL/Jlab) of 1st article electrical grade modules |  | 62d | 2011-09-01 | 2011-11-30 | 142211150 FS-2d, 142211160c FS-62d | 21d | 0d | PROCUREMENT<$50K 60 NO ESCALATION; PROCUREMENT>$50K 69 NO ESCALATION | 72,002 | ELOUADRHIRI L | 1 | 1 |  | LATIFA E | 11-005 |  |  | 12-013 |  |  |  |  |  | 13-002F |  |  |  |  | Pat |  | 11-058 |  |  | 12-027F |  |
| 142211160f |  | FNAL Design of Assembly Fixtures (6.5 months) |  | 268d | 2011-09-01 | 2012-09-28 | 142211160d FS-62d | 21d | 0d | PROCUREMENT>$50K 69 NO ESCALATION | 37,130 | ELOUADRHIRI L | 1 | 1 |  | LATIFA E | 11-005 |  |  | 12-013 |  |  |  |  |  | 13-002F |  |  |  |  | Pat |  | 11-058 |  |  | 12-027 |  |
| 142211160g |  | FNAL Receive & test (Jlab/FNAL) R1-R3 Production Sensors (4 batches) Part A |  | 327d | 2011-09-01 | 2012-12-31 | 142211005k FS-250d, 142211160f FS-268d | 31d | 11d | PROCUREMENT>$50K 69 NO ESCALATION | 61,681 | ELOUADRHIRI L | 1 | 1 |  | LATIFA E | 11-005 |  |  | 12-013 |  |  |  |  |  | 13-002F |  |  |  |  | Pat |  | 11-058 |  |  | 12-027 |  |
| 142211240 |  | BST R1-R3 HBI - 8 DAq: VME: (2) crates and cards - Proc |  | 21d | 2011-09-01 | 2011-09-30 | 142211235 | 297d | 0d | PROCUREMENT<$50K 60 | 26,182 | ELOUADRHIRI L | 1 | 1 |  | LATIFA E | 11-005 |  |  | 12-013 |  |  |  |  |  | 13-002F |  |  |  |  | Pat | HBI | 11-058 | 12-054F |  |  |  |
| 142211310 |  | BST R1-R3 MECH GRP - Support structure for cold plate 1st article tests: procurement prep - Labor FY11 |  | 14d | 2011-09-13 | 2011-09-30 | 142211305 | 286d | 0d | MECH ENG [26.67 h] | 1,812.23 | ELOUADRHIRI L | 1 | 1 |  | LATIFA E | 11-005 |  |  | 12-013 |  |  |  |  |  | 13-002F |  |  |  |  | Pat | MECH | 11-058 | 12-054F | 12-001 |  |  |
| 142211012E |  | SVT-FY12 Travel |  | 247d | 2011-10-03 | 2012-09-28 | 142211011E, 142211004a | 20d | 0d | TRAVEL | 4,680.02 | ELOUADRHIRI L | 1 | 1 | 07-024 | LATIFA E | 11-005 | 11-026 | 11 -035 | 12-013 |  |  |  |  |  |  |  |  |  |  |  |  |  |  |  |  |  |
| 142211115a |  | HBI - Hardware infrastructure: configuring and installing- Labor FY12 |  | 84d | 2011-10-03 | 2012-02-08 | 142211115 | 411d |  | ELEC TECH [125.61 h] | 5,543.17 | ELOUADRHIRI L | 1 | 1 |  | LATIFA E | 11-005 |  |  |  |  |  |  |  |  | 13-002F |  |  |  |  | Pat | HBI |  |  | 12-001 |  |  |
| 142211125 |  | HBI - SVT Engineering and Construction Oversight FY12 |  | 247d | 2011-10-03 | 2012-09-28 | 142211120 | 20d | 0d | SCIENTIST [1470 h] | 103,796.7 | ELOUADRHIRI L | 1 | 1 |  | LATIFA E | 11-005 |  |  |  |  |  |  |  |  |  |  |  |  |  | Pat | HBI |  |  | 12-001 |  |  |
| 142211145a |  | BST R1-R3 HBI - 2 Sensors: Sensors received and inspected by JLab (1st article and production) - Labor FY12 |  | 247d | 2011-10-03 | 2012-09-28 | 142211145 | 21d | 0d | ELEC TECH [377.58 h]; SCIENTIST [188.79 h]; ELEC ENG [377.58 h] | 56,635.11 | ELOUADRHIRI L | 1 | 1 |  | LATIFA E | 11-005 |  |  | 12-013 |  |  |  |  |  | 13-002F |  |  |  |  | Pat | HBI | 11-058 |  | 12-001 | 12-027F | 12-053 |
| 142211165a |  | BST R1-R3 HBI - 3: Modules: DAq development front end electronics (1st article) - Labor FY12 |  | 162d | 2011-10-03 | 2012-05-30 | 142211165 | 20d | 0d | SCIENTIST [629.13 h]; ELEC ENG [629.13 h] | 88,814.28 | ELOUADRHIRI L | 1 | 1 |  | LATIFA E | 11-005 |  |  | 12-013 |  |  |  |  |  | 13-002F |  |  |  |  | Pat | HBI | 11-058 |  | 12-001 |  |  |
| 142211170a |  | BST R1-R3 HBI - 4: DAq: 1st article software - Labor FY12 |  | 160d | 2011-10-03 | 2012-05-25 | 142211170 | 20d | 0d | SCIENTIST [470.59 h]; ELEC ENG [470.59 h] | 66,433.19 | ELOUADRHIRI L | 1 | 1 |  | LATIFA E | 11-005 |  |  | 12-013 |  |  |  |  |  | 13-002F |  |  |  |  | Pat | HBI | 11-058 |  | 12-001 |  |  |
| 142211195a |  | BST R1-R3 HBI - 6: Cable assemblies: HV, LV, and data (1) specifications and procurement prep - Labor FY12 |  | 15d | 2011-10-03 | 2011-10-21 | 142211195 | 251d | 0d | MECH TECH [10.17 h]; ELEC ENG [10.17 h] | 1,169.55 | ELOUADRHIRI L | 1 | 1 |  | LATIFA E | 11-005 |  |  |  |  |  |  |  |  | 13-002F |  |  |  |  | Pat | HBI | 11-058 |  | 12-001 |  |  |
| 142211215a |  | BST R1-R3 HBI - 7 Sloco: HV, LV, PS (1) module components and crates specs and procurement prep - Labor FY12 |  | 84d | 2011-10-03 | 2012-02-08 | 142211215 | 83d | 63d | MECH TECH [26.25 h]; ELEC ENG [26.25 h] | 3,018.75 | ELOUADRHIRI L | 1 | 1 |  | LATIFA E | 11-005 |  |  | 12-013 |  |  |  |  |  | 13-002F |  |  |  |  | Pat | HBI | 11-058 | 12-054F | 12-001 |  |  |
| 142211245 |  | BST R1-R3 HBI - 8 DAq: VME: (3) 1st article testing - Labor |  | 86d | 2011-10-03 | 2012-02-10 | 142211240 | 297d | 277d | ELEC TECH [160 h]; SCIENTIST [160 h]; ELEC ENG [160 h] | 29,648 | ELOUADRHIRI L | 1 | 1 |  | LATIFA E | 11-005 |  |  | 12-013 |  |  |  |  |  | 13-002F |  |  |  |  | Pat | HBI | 11-058 | 12-054F |  |  |  |
| 142211260 |  | BST R1-R3 HBI - 9 DAq-SCM (1) components and PCBs: specification and procurement prep - Labor |  | 58d | 2011-10-03 | 2011-12-30 | 142211109M, 9-120M | 168d | 0d | MECH TECH [40 h]; ELEC ENG [40 h] | 4,600 | ELOUADRHIRI L | 1 | 1 |  | LATIFA E | 11-005 |  |  |  |  |  |  |  |  | 13-002F |  |  |  |  | Pat | HBI |  |  |  |  |  |
| 142211265 |  | BST R1-R3 HBI - 9 DAq-SCM (2) system for 1st article - Proc |  | 58d | 2011-10-03 | 2011-12-30 | 142211260 FS-58d | 168d | 63d | PROCUREMENT<$50K 60 | 30,957 | ELOUADRHIRI L | 1 | 1 |  | LATIFA E | 11-005 |  |  |  |  |  |  |  |  | 13-002F |  |  |  |  | Pat | HBI |  |  |  |  |  |

Notes:
- 142211110: Explanation: Phase / Procurement / Labor / Total $ / 1 / 125,000 / 2 / 75,000 / 3 / 100,000 / protective enclosure for F1 F2 F3 F4 / 12,500 / protective enclosure for R1 R2 R3 R4 / 12,500 / Phase 1 / Activity ID / Procurement / Labor / Total $ / Phase 2 / Activity ID / Procurement / Labor / Total $ / Phase 3 / Activity ID / Procurement / Labor / Total $
- 142211140: Explanation: dicing (Mosis) $40,880, testing / (TestEdge) $36,300, testing/Jlab (chuck adapter $360, probe card / adapter $2170, estimate for adapter board $1454) $3984 / Steps: Wafers; testing; JLab testing
- 142211190: Explanation: hybrid assembly boards(10) $13,300, connectors $4540 / Vendor (MSU/FNAL) will die mount / added time and $ for population $2,871
- 142211240: Explanation: crates (2 @ $9,016) $18,032, controller cards (2 @ / $4075) $8150(includes 30% volume increase)
- 142211265: Explanation: Engineering estimate based on quotes, ~$3k for the current / PCI DAQ board setup. SCM to contain multiple data connectors, a larger / FPGA, and additional connectors to DAQ, thus $6k per board. 5 boards / needed for 1st article.

| ID | Activity | Type | Duration | Start | Finish | Predecessors | Total float | Free float | Resources | Cost | RESP - Responsibility | STRT%COMP for CM EVM | FNSH%COMP for CM EVM | CAM RESPONSIBLE | Pat's Code | CR 11-005 | SVT | CR 11-058 | CR 12-001 | CR 12-013 | CR 12-054 | CR 13-002 | CR 12-027 | CR 13-014 | CR 12-053 | CR 12-055 | CR 07-024 | CR 11-026 | CR 11-035 |
| --- | --- | --- | --- | --- | --- | --- | --- | --- | --- | --- | --- | --- | --- | --- | --- | --- | --- | --- | --- | --- | --- | --- | --- | --- | --- | --- | --- | --- | --- |
| 142211285a | BST R1-R3 MECH GRP - Modules: 1st article cold plate manufacturing drawing - Labor FY12 |  | 40d | 2011-10-03 | 2011-11-29 | 142211285 | 226d | 0d | MECH ENG [114.29 h]; MECH DES [114.29 h]; ELEC ENG [76.19 h] | 18,895.33 | ELOUADRHIRI L | 1 | 1 | LATIFA E | Pat | 11-005 | MECH | 11-058 | 12-001 | 12-013 | 12-054F | 13-002F |  |  |  |  |  |  |  |
| 142211310a | BST R1-R3 MECH GRP - Support structure for cold plate 1st article tests: procurement prep - Labor FY12 |  | 7d | 2011-10-03 | 2011-10-11 | 142211310 | 286d | 0d | MECH ENG [13.33 h] | 934.7 | ELOUADRHIRI L | 1 | 1 | LATIFA E | Pat | 11-005 | MECH | 11-058 | 12-001 | 12-013 | 12-054F | 13-002F |  |  |  |  |  |  |  |
| 142211315 | BST R1-R3 MECH GRP - Support structure to hold 1st article tests for cold plate: (1) procurement - Proc |  | 44d | 2011-10-12 | 2011-12-14 | 142211310a | 286d | 0d | PROCUREMENT<$50K 60 | 5,159.5 | ELOUADRHIRI L | 1 | 1 | LATIFA E | Pat | 11-005 | MECH | 11-058 |  | 12-013 | 12-054F | 13-002F |  |  |  |  |  |  |  |
| 142211200 | BST R1-R3 HBI - 6: Cable assemblies: HV, LV, and data (3) assemble components for fabrication - Labor |  | 61d | 2011-10-24 | 2012-01-27 | 142211195a | 251d | 0d | ELEC TECH [160 h] | 7,060.8 | ELOUADRHIRI L | 1 | 1 | LATIFA E | Pat | 11-005 | HBI | 11-058 |  |  |  | 13-002F |  |  |  |  |  |  |  |
| 142211205 | BST R1-R3 HBI - 6: Cable assemblies: HV, LV, and data (4) 1st article - Proc |  | 61d | 2011-10-24 | 2012-01-27 | 142211200 FS-61d | 251d | 64d | PROCUREMENT<$50K 60 | 21,759.68 | ELOUADRHIRI L | 1 | 1 | LATIFA E | Pat | 11-005 | HBI | 11-058 |  |  |  | 13-002F |  |  |  |  |  |  |  |
| 142211325 | BST R1-R3 MECH GRP - Modules:for assy 1st article BST, mounting, and alignment fixture -mfg dwgs |  | 43d | 2011-10-31 | 2012-01-09 | 142211285a FS-20d, 142211280 FS-162d | 237d | 63d | MECH ENG [80 h]; MECH DES [80 h] | 9,463.2 | ELOUADRHIRI L | 1 | 1 | LATIFA E | Pat | 11-005 | MECH | 11-058 |  | 12-013 | 12-054F | 13-002F | 12-027F |  |  |  |  |  |  |
| 142211290 | BST R1-R3 MECH GRP - Cold plate 1st article model: procurement prep - Labor |  | 21d | 2011-11-30 | 2012-01-05 | 142211285a | 226d | 63d | MECH ENG [40 h] | 2,804.8 | ELOUADRHIRI L | 1 | 1 | LATIFA E | Pat | 11-005 | MECH | 11-058 |  | 12-013 | 12-054F | 13-002F |  |  |  |  |  |  |  |
| 142211320 | BST R1-R3 MECH GRP - Support structure to hold 1st art. tests for cold plate (2) constr/assem (for burn-in tests) - Lab |  | 46d | 2011-12-15 | 2012-02-28 | 142211315 | 286d | 266d | MECH ENG [40 h]; MECH TECH [80 h] | 6,360 | ELOUADRHIRI L | 1 | 1 | LATIFA E | Pat | 11-005 | MECH | 11-058 |  | 12-013 | 12-054F | 13-002F |  |  |  |  |  |  |  |
| 142211405 | BST R1-R3 MECH GRP - Protective enclosure system (1) Manufacturing Drawings - Labor |  | 32d | 2011-12-16 | 2012-02-08 | 142211109M FS+96d | 371d | 0d | ELEC TECH [40 h]; MECH TECH [40 h] | 3,542.8 | ELOUADRHIRI L | 1 | 1 | LATIFA E | Pat | 11-005 | MECH |  |  |  | 12-054F | 13-002F | 12-027F |  |  |  |  |  |  |
| 142211450 | BST R1-R3 MECH GRP - Cooling system: preparation, manufacturing drawings - Labor |  | 50d | 2011-12-29 | 2012-03-12 | 142211109M FS+100d | 217d | 0d | ELEC ENG [80 h]; MECH ENG [120 h]; MECH TECH [40 h]; MECH DES [80 h] | 19,690.4 | ELOUADRHIRI L | 1 | 1 | LATIFA E | Pat | 11-005 | MECH | 11-058 |  | 12-013 | 12-054F | 13-002F |  |  |  |  |  |  |  |
| 142211160h | FNAL Receive & test (Jlab/FNAL) R1-R3 Production Sensors (4 batches) Part B |  | 229d | 2012-01-31 | 2012-12-31 | 142211160g FS-240d, 142211005k FS-151d | 20d | 0d | PROCUREMENT<$50K 60 NO ESCALATION | 2,601 | ELOUADRHIRI L | 1 | 1 | LATIFA E | Pat | 11-005 |  | 11-058 |  | 12-013 |  | 13-002F | 12-027 |  |  |  |  |  |  |
| 142211160j | FNAL QA/QC and Assembly of Fixtures |  | 250d | 2012-01-31 | 2013-01-31 | 142211160h FS-229d, 142211255a FS-151d, 142211255 FS-151d | 20d | 0d | PROCUREMENT<$50K 60 NO ESCALATION | 42,294 | ELOUADRHIRI L | 1 | 1 | LATIFA E | Pat | 11-005 |  | 11-058 |  | 12-013 |  | 13-002F | 12-027F |  |  |  |  |  |  |
| 142211160k | FNAL Construction of 1st article (mechanical grade) modules |  | 250d | 2012-01-31 | 2013-01-31 | 142211160j FS-250d | 20d | 0d | PROCUREMENT<$50K 60 NO ESCALATION; PROCUREMENT>$50K 69 NO ESCALATION | 91,472 | ELOUADRHIRI L | 1 | 1 | LATIFA E | Pat | 11-005 |  | 11-058 |  | 12-013 |  | 13-002F |  |  |  |  |  |  |  |
| 142211160n | FNAL design and construct module shipping containers |  | 250d | 2012-01-31 | 2013-01-31 | 142211160k FS-250d | 20d | 0d | PROCUREMENT>$50K 69 NO ESCALATION | 21,100 | ELOUADRHIRI L | 1 | 1 | LATIFA E | Pat | 11-005 |  | 11-058 |  | 12-013 |  | 13-002F |  |  |  |  |  |  |  |
| 142211160p | FNAL/Jlab/MSU Testing of 1st article (mechanical grade) modules |  | 250d | 2012-01-31 | 2013-01-31 | 142211180 FS-127d, 142211160n FS-250d, 142211165a FS-85d | 20d | 0d | PROCUREMENT>$50K 69 NO ESCALATION | 11,528 | ELOUADRHIRI L | 1 | 1 | LATIFA E | Pat | 11-005 |  | 11-058 |  | 12-013 |  | 13-002F |  |  |  |  |  |  |  |
| 142211160q | FNAL/Jlab review of module testing |  | 250d | 2012-01-31 | 2013-01-31 | 142211160p FS-250d | 20d | 0d | PROCUREMENT>$50K 69 NO ESCALATION | 22,248 | ELOUADRHIRI L | 1 | 1 | LATIFA E | Pat | 11-005 |  | 11-058 |  | 12-013 |  | 13-002F |  |  |  |  |  |  |  |
| 142211160r | FNAL/Jlab revise module construction & assembly & QA/QC procedures |  | 250d | 2012-01-31 | 2013-01-31 | 142211160q FS-250d | 20d | 0d | PROCUREMENT>$50K 69 NO ESCALATION | 5,764 | ELOUADRHIRI L | 1 | 1 | LATIFA E | Pat | 11-005 |  | 11-058 |  | 12-013 |  | 13-002F |  |  |  |  |  |  |  |
| 142211160s | FNAL QA/QC and assembly of production fixtures |  | 250d | 2012-01-31 | 2013-01-31 | 142211160r FS-250d | 20d | 0d | PROCUREMENT>$50K 69 NO ESCALATION | 38,853 | ELOUADRHIRI L | 1 | 1 | LATIFA E | Pat | 11-005 |  | 11-058 |  | 12-013 |  | 13-002F |  |  |  |  |  |  |  |
| 142211160t | FNAL Construction and test (Jlab/FNAL) of R1-R3 production modules (60 modules) Part A |  | 398d | 2012-01-31 | 2013-08-30 | 142211160s FS-250d | 20d |  | PROCUREMENT>$50K 69 NO ESCALATION | 983.02 | ELOUADRHIRI L | 1 | 1 | LATIFA E | Pat | 11-005 |  | 11-058 |  | 12-013 |  | 13-002F |  | 13-014 |  |  |  |  |  |
| 142211385 | BST R1-R3 HBI - 7 Sloco: Slow controls and charge calibration system: (1) specification and procurement prep - Labor |  | 58d | 2012-02-09 | 2012-05-01 | 142211160, 142211190 | 253d | 0d | MECH TECH [40 h]; ELEC ENG [40 h] | 4,600 | ELOUADRHIRI L | 1 | 1 | LATIFA E | Pat | 11-005 | HBI | 11-058 |  |  |  | 13-002F | 12-027F |  |  |  |  |  |  |
| 142211410 | BST R1-R3 MECH GRP - Protective enclosure system (1) specifications and procurement prep - Labor |  | 40d | 2012-02-09 | 2012-04-05 | 142211405 | 371d |  | MECH TECH [40 h]; ELEC TECH [40 h] | 3,542.8 | ELOUADRHIRI L | 1 | 1 | LATIFA E | Pat | 11-005 | MECH |  |  |  | 12-054F | 13-002F | 12-027F |  |  |  |  |  |  |
| 142211455 | BST R1-R3 MECH GRP - Cooling system: preparation, procurement prep- Labor |  | 20d | 2012-03-13 | 2012-04-09 | 142211450 | 217d | 0d | MECH ENG [40 h] | 2,804.8 | ELOUADRHIRI L | 1 | 1 | LATIFA E | Pat | 11-005 | MECH | 11-058 |  | 12-013 | 12-054F | 13-002F |  |  |  |  |  |  |  |
| 142211270 | BST R1-R3 HBI - 9 DAq-SCM (3) custom crate fabrication and 1st article testing - Labor |  | 40d | 2012-04-03 | 2012-05-29 | 9-120M FS+121d, 142211265 | 105d | 0d | ELEC ENG [80 h]; ELEC TECH [160 h] | 12,705.6 | ELOUADRHIRI L | 1 | 1 | LATIFA E | Pat | 11-005 | HBI |  |  | 12-013 |  | 13-002F |  |  |  |  |  |  |  |
| 142211275 | BST R1-R3 HBI - 9 DAq-SCM (4) develop program and test (1/2) - Labor FY12 |  | 126d | 2012-04-03 | 2012-09-28 | 142211270 FS-40d | 105d | 0d | SCIENTIST [298.22 h]; ELEC ENG [298.22 h] | 42,099.71 | ELOUADRHIRI L | 1 | 1 | LATIFA E | Pat | 11-005 | HBI |  |  | 12-013 |  | 13-002F |  |  | 12-053 |  |  |  |  |
| 142211295 | BST R1-R3 MECH GRP - Cold plate 1st article tests: (1) procurement - Proc |  | 58d | 2012-04-06 | 2012-06-28 | 142211290, 9-120M FS+124d | 163d | 0d | PROCUREMENT<$50K 60 | 8,255.2 | ELOUADRHIRI L | 1 | 1 | LATIFA E | Pat | 11-005 | MECH | 11-058 |  | 12-013 | 12-054F | 13-002F |  |  |  |  |  |  |  |
| 142211330 | BST R1-R3 MECH GRP - Modules:for assy 1st article BST, mounting, and alignment fixture - proc prep - Labor |  | 21d | 2012-04-10 | 2012-05-08 | 142211325, 9-120M FS+126d | 174d | 0d | MECH ENG [40 h] | 2,804.8 | ELOUADRHIRI L | 1 | 1 | LATIFA E | Pat | 11-005 | MECH | 11-058 |  | 12-013 | 12-054F | 13-002F | 12-027F |  |  |  |  |  |  |
| 142211460 | BST R1-R3 MECH GRP - Cooling system: procurement - proc |  | 40d | 2012-04-10 | 2012-06-06 | 142211455 | 217d | 197d | PROCUREMENT<$50K 60 | 7,739.25 | ELOUADRHIRI L | 1 | 1 | LATIFA E | Pat | 11-005 | MECH | 11-058 |  | 12-013 | 12-054F | 13-002F |  |  |  |  |  |  |  |
| 142211210 | BST R1-R3 HBI - 6: Cable assemblies: HV, LV, and data (5) 1st article testing - Labor |  | 64d | 2012-04-30 | 2012-07-30 | 9-120M FS+140d, 142211205 | 187d | 0d | ELEC TECH [160 h] | 7,060.8 | ELOUADRHIRI L | 1 | 1 | LATIFA E | Pat | 11-005 | HBI | 11-058 |  | 12-013 |  | 13-002F |  |  |  |  |  |  |  |
| 142211430 | BST R1-R3 HBI - 7 Sloco-Slow controls charge calibration system: develop slow controls (2/2) - Labor |  | 100d | 2012-05-02 | 2012-09-21 | 142211385 | 253d |  | SCIENTIST [160 h]; ELEC ENG [80 h] | 16,942.4 | ELOUADRHIRI L | 1 | 1 | LATIFA E | Pat | 11-005 | HBI | 11-058 |  |  |  | 13-002F |  |  |  |  |  |  |  |
| 142211220 | BST R1-R3 HBI - 7 Sloco: HV, LV, PS (2) modules 1st article - Proc |  | 65d | 2012-05-09 | 2012-08-09 | 142211215a, 9-120M FS+147d | 20d | 0d | PROCUREMENT<$50K 60 | 29,469 | ELOUADRHIRI L | 1 | 1 | LATIFA E | Pat | 11-005 | HBI | 11-058 |  | 12-013 | 12-054F | 13-002F |  |  |  |  |  |  |  |
| 142211335 | BST R1-R3 MECH GRP - Modules: round table, mounting, and alignment fixture (1) procurement - Proc |  | 100d | 2012-05-09 | 2012-09-28 | 142211330 | 174d | 0d | PROCUREMENT<$50K 60 | 9,837.1 | ELOUADRHIRI L | 1 | 1 | LATIFA E | Pat | 11-005 | MECH | 11-058 |  | 12-013 | 12-054F | 13-002F | 12-027 |  |  |  |  |  |  |
| 142211175 | BST R1-R3 HBI - 4: DAq: readout card 1st article - Proc |  | 23d | 2012-05-29 | 2012-06-29 | 142211170a | 20d | 0d | PROCUREMENT<$50K 60 | 30,957 | ELOUADRHIRI L | 1 | 1 | LATIFA E | Pat | 11-005 | HBI | 11-058 |  | 12-013 |  | 13-002F |  |  |  |  |  |  |  |
| 142211255 | BST JLab - Tooling Production Part A |  | 65d | 2012-06-01 | 2012-08-31 | 9-120M FS+163d, 142211160f FS-85d | 20d | 0d | PROCUREMENT<$50K 60 | 5,000 | ELOUADRHIRI L | 1 | 1 | LATIFA E | Pat | 11-005 |  | 11-058 |  | 12-013 |  | 13-002F |  |  |  | 12-055 |  |  |  |
| 142211255a | BST JLab - Tooling Production Part B |  | 65d | 2012-06-01 | 2012-08-31 | 142211160f FS-85d, 9-120M FS+163d | 20d | 0d | PROCUREMENT<$50K 60 | 20,797.5 | ELOUADRHIRI L | 1 | 1 | LATIFA E | Pat | 11-005 |  | 11-058 |  | 12-013 |  | 13-002F |  |  |  | 12-055 |  |  |  |
| 142211300 | BST R1-R3 MECH GRP - Cold plate 1st article tests: (2) construct and assemble - Labor |  | 38d | 2012-06-29 | 2012-08-21 | 142211295 | 163d | 143d | MECH TECH [80 h]; MECH ENG [40 h] | 6,360 | ELOUADRHIRI L | 1 | 1 | LATIFA E | Pat | 11-005 | MECH | 11-058 |  | 12-013 | 12-054F | 13-002F |  |  |  |  |  |  |  |
| 142211180 | BST R1-R3 HBI - 4: DAq: readout card R1 R2 R3 - Proc |  | 21d | 2012-07-02 | 2012-07-30 | 142211175 | 20d | 0d | PROCUREMENT<$50K 60 | 18,574.2 | ELOUADRHIRI L | 1 | 1 | LATIFA E | Pat | 11-005 | HBI | 11-058 |  | 12-013 |  | 13-002F |  |  |  |  |  |  |  |
| 142211340 | BST R1-R3 MECH GRP - 3: Modules: round table, mounting, and alignment fixture (2) construction - Labor |  | 22d | 2012-07-06 | 2012-08-06 | 9-120M FS+76d, 142211335 FS-60d | 174d | 154d | MECH TECH [80 h] | 3,555.2 | ELOUADRHIRI L | 1 | 1 | LATIFA E | Pat | 11-005 | MECH | 11-058 |  | 12-013 | 12-054F | 13-002F | 12-027 |  |  |  |  |  |  |
| 142211390 | BST R1-R3 HBI - 7 Sloco: Slow controls for monitoring and charge calibration system: (2) component procurement - Proc |  | 136d | 2012-07-12 | 2013-01-31 | 9-120M FS+191d, 142211385 FS-115d | 164d | 0d | PROCUREMENT<$50K 60 NO ESCALATION FY13 | 32,576.05 | ELOUADRHIRI L | 1 | 1 | LATIFA E | Pat | 11-005 | HBI | 11-058 |  |  | 12-054 | 13-002F | 12-027 |  |  |  |  |  |  |
| 142211365 | BST R1-R3 HBI - 6: Cable assemblies: HV, LV, and data (6) R1 R2 R3 - Proc Part A |  | 44d | 2012-07-31 | 2012-10-01 | 142211210 | 187d | 0d | PROCUREMENT<$50K 60 NO ESCALATION FY13 | 10,000 | ELOUADRHIRI L | 1 | 1 | LATIFA E | Pat | 11-005 | HBI |  |  | 12-013 |  | 13-002F |  |  |  | 12-055 |  |  |  |
| 142211365a | BST R1-R3 HBI - 6: Cable assemblies: HV, LV, and data (6) R1 R2 R3 - Proc Part B |  | 44d | 2012-07-31 | 2012-10-01 | 142211210 | 187d | 0d | PROCUREMENT<$50K 60 NO ESCALATION FY13 | 27,374.39 | ELOUADRHIRI L | 1 | 1 | LATIFA E | Pat | 11-005 | HBI |  |  | 12-013 |  | 13-002F |  |  |  | 12-055 |  |  |  |
| 142211225 | BST R1-R3 HBI - 7 Sloco: HV, LV, PS (3) modules components: 1st article testing - Labor |  | 31d | 2012-08-10 | 2012-09-24 | 142211220 | 20d | 0d | ELEC ENG [40 h]; ELEC TECH [160 h] | 9,883.2 | ELOUADRHIRI L | 1 | 1 | LATIFA E | Pat | 11-005 | HBI | 11-058 |  | 12-013 | 12-054F | 13-002F |  |  |  |  |  |  |  |
| 142211230 | BST R1-R3 HBI - 7 Sloco: HV, LV, PS (4) crates - Proc (1st Articles and Production) |  | 31d | 2012-08-10 | 2012-09-24 | 142211220 | 74d | 0d | PROCUREMENT<$50K 60 | 35,660.4 | ELOUADRHIRI L | 1 | 1 | LATIFA E | Pat | 11-005 | HBI | 11-058 |  | 12-013 | 12-054F | 13-002F |  |  |  |  |  |  |  |
| 142211400 | BST R1-R3 HBI - 7Sloco:Slow controls for monitor and charge calib system: (4) develop sloco software (1/2) - Labor |  | 16d | 2012-09-07 | 2012-09-28 | 142211395 FS-121d | 164d | 0d | SCIENTIST [25.6 h]; ELEC ENG [12.8 h] | 2,710.79 | ELOUADRHIRI L | 1 | 1 | LATIFA E | Pat | 11-005 | HBI | 11-058 |  |  | 12-054F | 13-002F | 12-027 |  | 12-053 |  |  |  |  |
| 142211375 | BST R1-R3 HBI - 7 Sloco: HV, LV, PS (1) modules R1 R2 R3 - Proc |  | 58d | 2012-09-25 | 2012-12-17 | 142211230, 142211109M | 74d | 0d | PROCUREMENT<$50K 60 NO ESCALATION FY13; PROCUREMENT>$50K 69 NO ESCALATION FY13 | 88,407 | ELOUADRHIRI L | 1 | 1 | LATIFA E | Pat | 11-005 | HBI |  |  | 12-013 |  | 13-002F |  |  |  |  |  |  |  |
| 142211355M | Start of R1-R3 Production | milestone | 0d | 2012-09-26 | 2012-09-26 | 142211350M FS-140d | 37d | 0d |  |  | ELOUADRHIRI L | 1 | 1 | LATIFA E | Pat | 11-005 | MECH | 11-058 |  | 12-013 | 12-054F | 13-002F |  |  |  |  |  |  |  |
| 142211360 | BST R1-R3 HBI - Electronics 5: HFCB modules R1 R2 R3 - Proc |  | 58d | 2012-09-26 | 2012-12-18 | 142211140, 142211190, 142211355M | 37d | 0d | PROCUREMENT<$50K 60 NO ESCALATION FY13; PROCUREMENT>$50K 69 NO ESCALATION FY13 | 124,266.56 | ELOUADRHIRI L | 1 | 1 | LATIFA E | Pat | 11-005 | HBI | 11-058 |  | 12-013 | 12-054F | 13-002F |  |  |  |  |  |  |  |
| 142211013E | SVT-FY13 Travel |  | 228d | 2012-10-01 | 2013-08-30 | 142211012E | 20d |  | TRAVEL | 4,439.85 | ELOUADRHIRI L | 1 | 1 | LATIFA E |  | 11-005 |  |  |  | 12-013 |  |  |  | 13-014 |  |  | 07-024 | 11-026 | 11 -035 |
| 142211130 | HBI - SVT Engineering and Construction Oversight FY13 |  | 228d | 2012-10-01 | 2013-08-30 | 142211125 | 20d |  | SCIENTIST [1241.13 h] | 90,428.73 | ELOUADRHIRI L | 1 | 1 | LATIFA E | Pat | 11-005 | HBI |  | 12-001 |  |  |  |  | 13-014 |  |  |  |  |  |
| 142211145aa | BST R1-R3 HBI - 2 Sensors: Sensors received and inspected by JLab (1st article and production) - Labor FY13 |  | 23d | 2012-10-01 | 2012-10-31 | 142211145a | 21d | 0d | ELEC TECH [35.16 h]; SCIENTIST [17.58 h]; ELEC ENG [35.16 h] | 5,442.07 | ELOUADRHIRI L | 1 | 1 | LATIFA E | Pat | 11-005 | HBI | 11-058 | 12-001 | 12-013 |  | 13-002F | 12-027F |  | 12-053 |  |  |  |  |
| 142211275a | BST R1-R3 HBI - 9 DAq-SCM (4) develop program and test (1/2) - Labor FY13 |  | 43d | 2012-10-01 | 2012-11-30 | 142211275 | 105d | 0d | SCIENTIST [101.78 h]; ELEC ENG [101.78 h] | 14,826.29 | ELOUADRHIRI L | 1 | 1 | LATIFA E | Pat | 11-005 | HBI |  |  | 12-013 |  | 13-002F |  |  | 12-053 |  |  |  |  |
| 142211400a | BST R1-R3 HBI - 7Sloco:Slow controls for monitor and charge calib system: (4) develop sloco software (1/2) - Labor FY13 |  | 84d | 2012-10-01 | 2013-02-06 | 142211400 | 164d |  | SCIENTIST [134.4 h]; ELEC ENG [67.2 h] | 14,685.21 | ELOUADRHIRI L | 1 | 1 | LATIFA E | Pat | 11-005 | HBI | 11-058 |  |  | 12-054F | 13-002F | 12-027 |  | 12-053 |  |  |  |  |
| 142211530 | BST R4 HBI - 6: Cable assemblies: HV, LV, and data (1) R4 - Proc |  | 80d | 2012-10-01 | 2013-01-31 | 9-130M | 88d | 0d | PROCUREMENT<$50K 60 | 19,581.99 | ELOUADRHIRI L | 1 | 1 | LATIFA E | Pat | 11-005 | HBI |  |  |  |  | 13-002F |  |  |  |  |  |  |  |
| 142211540 | BST R4 HBI - 7 Sloco: HV, LV, PS (1) modules R4 - Proc |  | 80d | 2012-10-01 | 2013-01-31 | 9-130M | 168d |  | PROCUREMENT>$50K 69; PROCUREMENT<$50K 60 | 60,818.12 | ELOUADRHIRI L | 1 | 1 | LATIFA E | Pat | 11-005 | HBI |  |  |  |  | 13-002F |  |  |  |  |  |  |  |
| 142211550 | BST R4 HBI - 9 DAq- SCM custom crate system components R4 - Proc |  | 23d | 2012-10-01 | 2012-10-31 | 9-130M | 225d |  | PROCUREMENT<$50K 60 | 38,333.43 | ELOUADRHIRI L | 1 | 1 | LATIFA E | Pat | 11-005 | HBI |  |  |  |  | 13-002F |  |  |  |  |  |  |  |
| 142211840 | Installation MECH GRP - Installation cart: (1) MFG Drawings - Labor |  | 120d | 2012-10-01 | 2013-03-29 | 9-130M | 95d | 0d | MECH DES [240 h]; MECH ENG [80 h] | 17,719.2 | ELOUADRHIRI L | 1 | 1 | LATIFA E | Pat | 11-005 | MECH |  |  |  |  | 13-002F |  |  |  |  |  |  |  |
| 142211860 | Installation MECH GRP - Purging system: (1) procurement prep - Labor |  | 21d | 2012-10-01 | 2012-10-29 | 9-130M | 184d | 0d | MECH ENG [40 h] | 2,894.4 | ELOUADRHIRI L | 1 | 1 | LATIFA E | Pat | 11-005 | MECH |  |  |  |  | 13-002F |  |  |  |  |  |  |  |
| 142211875 | Installation MECH GRP - Transport box BST: (1) manufacturing drawings - Labor |  | 60d | 2012-10-01 | 2013-01-02 | 9-130M | 155d | 0d | MECH DES [80 h]; MECH ENG [80 h] | 9,765.6 | ELOUADRHIRI L | 1 | 1 | LATIFA E | Pat | 11-005 | MECH |  |  |  |  | 13-002F |  |  |  |  |  |  |  |
| 142211370 | BST R1-R3 HBI - 6: Cable assemblies: HV, LV, and data fabrication and testing - Labor |  | 60d | 2012-10-02 | 2013-01-03 | 142211365a, 142211365 | 187d |  | ELEC TECH [400 h] | 18,216 | ELOUADRHIRI L | 1 | 1 | LATIFA E | Pat | 11-005 | HBI |  |  | 12-013 |  | 13-002F |  |  |  |  |  |  |  |
| 142211395 | BST R1-R3 HBI - 7Sloco:Slow controls for monitoring and charge calib system: (3) assemble, test, and debug - Labor |  | 100d | 2012-10-08 | 2013-03-08 | 142211390 FS-75d | 164d | 0d | ELEC ENG [80 h]; ELEC TECH [480 h] | 27,684 | ELOUADRHIRI L | 1 | 1 | LATIFA E | Pat | 11-005 | HBI | 11-058 |  |  | 12-054 | 13-002F | 12-027 |  | 12-053 |  |  |  |  |
| 142211865 | Installation MECH GRP - Purging system: (2) installation - Proc |  | 22d | 2012-10-30 | 2012-11-30 | 142211860 | 184d | 0d | PROCUREMENT<$50K 60 | 5,324.09 | ELOUADRHIRI L | 1 | 1 | LATIFA E | Pat | 11-005 | MECH |  |  |  |  | 13-002F |  |  |  |  |  |  |  |
| 142211160v | FNAL Receive & test (Jlab/FNAL) R4 Production Sensors (3 batches) |  | 97d | 2012-11-01 | 2013-03-29 | 142211505 FS-40d | 128d |  | PROCUREMENT>$50K 69 | 1,105.28 | ELOUADRHIRI L | 1 | 1 | LATIFA E | Pat | 11-005 |  | 11-058 |  | 12-013 |  | 13-002F |  |  |  |  |  |  |  |
| 142211880 | Installation MECH GRP - Transport box BST: (2) procurement prep - Labor |  | 21d | 2012-11-09 | 2012-12-11 | 142211875 FS-31d | 155d | 0d | MECH ENG [40 h] | 2,894.4 | ELOUADRHIRI L | 1 | 1 | LATIFA E | Pat | 11-005 | MECH |  |  |  |  | 13-002F |  |  |  |  |  |  |  |
| 142211500M | Start of BST R4 Production | milestone | 0d | 2012-11-27 | 2012-11-27 | 142211005p, 9-130M FS+40d | 128d | 0d |  |  | ELOUADRHIRI L | 1 | 1 | LATIFA E | Pat | 11-005 | MECH | 11-058 |  |  |  | 13-002F |  |  |  |  |  |  |  |
| 142211505 | BST R4 HBI - 2 Sensors: Sensors for R4 - Proc |  | 23d | 2012-11-28 | 2013-01-07 | 142211500M, 142211005p FS-78d | 128d | 0d | PROCUREMENT>$50K 69; PROCUREMENT<$50K 60 | 354,200.93 | ELOUADRHIRI L | 1 | 1 | LATIFA E | Pat | 11-005 | HBI | 11-058 |  |  |  | 13-002F |  |  |  |  |  |  |  |
| 142211435 | BST R1-R3 HBI - 9 DAq-SCM (1) custom crate system components R1 R2 R3 - Proc |  | 59d | 2012-12-03 | 2013-03-05 | 142211275a | 105d | 0d | PROCUREMENT<$50K 60; PROCUREMENT>$50K 69 | 102,222.49 | ELOUADRHIRI L | 1 | 1 | LATIFA E | Pat | 11-005 | HBI | 11-058 |  | 12-013 |  | 13-002F |  |  |  |  |  |  |  |
| 142211445 | BST R1-R3 HBI - 9 DAq-SCM (3) develop program and test (2/2) - Labor |  | 100d | 2012-12-03 | 2013-05-01 | 142211440 FS-120d | 105d |  | SCIENTIST [400 h]; ELEC ENG [400 h] | 58,268 | ELOUADRHIRI L | 1 | 1 | LATIFA E | Pat | 11-005 | HBI | 11-058 |  | 12-013 |  | 13-002F |  |  |  |  |  |  |  |
| 142211870 | Installation MECH GRP - Purging system: (3) installation - Labor |  | 21d | 2012-12-03 | 2013-01-08 | 142211865 | 184d |  | MECH DES [40 h]; MECH ENG [40 h]; MECH TECH [80 h] | 8,551.6 | ELOUADRHIRI L | 1 | 1 | LATIFA E | Pat | 11-005 | MECH |  |  |  |  | 13-002F |  |  |  |  |  |  |  |
| 142211885 | Installation MECH GRP - Transport box BST: (3) construct and assemble - Proc |  | 21d | 2012-12-12 | 2013-01-17 | 142211880 | 155d | 0d |  |  | ELOUADRHIRI L | 1 | 1 | LATIFA E | Pat | 11-005 | MECH |  |  |  |  | 13-002F |  |  |  |  |  |  |  |
| 142211380 | BST R1-R3 HBI - 7 Sloco: HV, LV, PS (3) distribution system (fabricate) - Labor |  | 120d | 2012-12-18 | 2013-06-14 | 142211375 | 74d |  | ELEC TECH [480 h] | 21,859.2 | ELOUADRHIRI L | 1 | 1 | LATIFA E | Pat | 11-005 | HBI |  |  | 12-013 |  | 13-002F |  |  |  |  |  |  |  |
| 142211510 | BST R4 HBI - 5 Electronics: HFCB production modules R4 - Proc |  | 59d | 2012-12-19 | 2013-03-21 | 9-130M, 142211360 | 37d | 0d | PROCUREMENT<$50K 60 | 39,470.66 | ELOUADRHIRI L | 1 | 1 | LATIFA E | Pat | 11-005 | HBI | 11-058 |  | 12-013 | 12-054F | 13-002F |  |  |  |  |  |  |  |

Notes:
- 142211205: Explanation: cable (1000') $2821.55, cable (1000') $795.73, connector molex (300 @ / 0.09472) $28.42, cable (2000') $11,300, connectors (40 @ 0.789) / $31.56, straight plug conncetor 37 pin (20 @ 124.13) $2482.60, / straight plug conncetor 51 pin (20 @ 181.36) / $3627.20
- 142211220: Explanation: HV modules (2 @ $9911) $19,822, MPOD module (3 @ $2912) $8736 (also / includes a 30% volume increase)
- 142211175: Explanation: DAq boards (PTA $1365.68, PMC $1334.96, Adapter / $322.11) $3023, PCB assembly (5 @ $1267.40) $6337, PCB / assembly $2459, PCB assembly (5 @ $1622.72) $8114, PMC board assembly (5 @ / $520.18) $2601, PMC/PTA adapter (5 @ $485.20) $2426, prototype board $1025 / Steps: wafers
- 142211180: Explanation: Engineering estimate based on quotes, ~$3k for the current / PCI DAQ board setup. Final version will be bigger PCBs with / additional VME circuitry, thus $6k per board. 3 boards needed for BST / regions 1-3.
- 142211390: Explanation: analog module $511.97, input module $511.97, 8-slot / backplane $608.75, LabVIEW real-time/Ethernet controller $1837.85, NI standard / system assurance program $250, PS-4 power supply $240.98, connector block (2 @ / 163.56) $327.12, LabVIEW real-time module $2515.31, optical module / $24,765
- 142211365: Explanation: cable (1000') $2821.55, cable (1000') $795.73, connectors / (1400 @ 0.0773) $108.26, connectors single row (212 @ 0.526) $111.51, straight / plug conncetor 37 pin (106 @ 124.13) $13,157.78, straight plug / conncetor 51 pin (106 @ 181.36) $19224.16
- 142211365a: Explanation: cable (1000') $2821.55, cable (1000') $795.73, connectors / (1400 @ 0.0773) $108.26, connectors single row (212 @ 0.526) $111.51, straight / plug conncetor 37 pin (106 @ 124.13) $13,157.78, straight plug / conncetor 51 pin (106 @ 181.36) $19224.16
- 142211230: Explanation: HV modules (2 @ $8877) $17,754, crates (2 @ / $8402) $16,804 (also includes a 30% volume increase)
- 142211375: Explanation: power supply (6 @ $9911) $59,466, MPOD module (9 @ $2912) $26,208,
- 142211360: Explanation: HFCB boards (63 @ $625) $39,375, setup $1400, electrical test / $650, connector head (126 @ $3.2578) $410.48, SMT conn. 37 pin (63 @ / $122.10) $7962.30, SMT conn. 51 pin (63 @ $180.54) $11,374.02, / additional board parts (63 @ $21.67) $1365.21
- 142211530: Explanation: cable (1000') $2821.55, cable (1000') $795.73, connectors / molex (650 @ 0.087) $57.00, connectors single row (100 @ 0.526) $52.60, straight / plug conncetor 37 pin (48 @ 124.13) $5958.24, straight plug / conncetor 51 pin (48 @ 181.36) $8705.28
- 142211540: Explanation: power supply (4 @ $9911) $39,644, MPOD module (6 @ 2912) / $17,472
- 142211550: Explanation: Engineering estimate based on quotes, ~$3k for the current / PCI DAQ board setup. SCM to contain multiple data connectors, a larger / FPGA, and additional connectors to DAQ, thus $6k per board. 6 boards / needed for BST R4. (24 modules with 4 modules per SCM)
- 142211505: Explanation: 216 sensors @ $1540; feeds into 2500L FY13 (R1 R2 R3); anticipate / receiving sensor in 3 months (Feb 13)
- 142211435: Explanation: Engineering estimate based on quotes, ~$3k for the current / PCI DAQ board setup. SCM to contain multiple data connectors, a larger / FPGA, and additional connectors to DAQ, thus $6k per board. 16 boards / needed for BST R1-R3. (63 modules with 4 modules per SCM)
- 142211510: Explanation: HFCB (24 boards @ $1125) $27,000, setup $1400, testing $650, connectors / (48 @ $4.887) $234.58, connectors (24 @ $122.10) $2930.40, connectors (24 @ / $180.54) $4332.96, additional board parts (24 @21.67) $520.08

| ID | Activity | Type | Duration | Start | Finish | Predecessors | Total float | Free float | Calendar | Resources | Cost | RESP - Responsibility | STRT%COMP for CM EVM | FNSH%COMP for CM EVM | CAM RESPONSIBLE | Pat's Code | CR 11-005 | SVT | CR 13-002 | CR 11-058 | CR 12-013 | CR 12-054 | CR 12-053 | CR 13-014 | ReBaseline Actuals Adjustment | Original Activity ID Rebaseline | CR 07-024 | EVMS Reporting Codes | CR 11-026 | CR 11-035 | BOE Expenses | CR 13-015 | Post Rebaseline | CR 12-001 | BOE Labor | Over Under Fixed | BOE Procurement | Obligated Prior to Rebaseline | CR 12-027 | Remaining Material Cost Based on % Compl | Claimed Material Cost Based on % Complet | Initial Claimed Material Calc | Claimed Material Divider | CR 12-055 | Activities with Steps | PRIOR MONTH EV COST | CR 14-001 |
| --- | --- | --- | --- | --- | --- | --- | --- | --- | --- | --- | --- | --- | --- | --- | --- | --- | --- | --- | --- | --- | --- | --- | --- | --- | --- | --- | --- | --- | --- | --- | --- | --- | --- | --- | --- | --- | --- | --- | --- | --- | --- | --- | --- | --- | --- | --- | --- |
| 142211890 | Installation MECH GRP - Transport box BST: (4) construct and assemble - Labor |  | 22d | 2013-01-18 | 2013-02-20 | 142211885 | 155d |  |  | MECH DES [80 h]; MECH ENG [80 h] | 9,765.6 | ELOUADRHIRI L | 1 | 1 | LATIFA E | Pat | 11-005 | MECH | 13-002F |  |  |  |  |  |  |  |  |  |  |  |  |  |  |  |  |  |  |  |  |  |  |  |  |  |  |  |  |
| 142211535 | BST R4 HBI - 6: Cable assemblies: HV, LV, and data (2) R4 - Labor |  | 80d | 2013-02-01 | 2013-05-24 | 142211530 | 88d |  |  | ELEC TECH [160 h] | 7,286.4 | ELOUADRHIRI L | 1 | 1 | LATIFA E | Pat | 11-005 | HBI | 13-002F |  |  |  |  |  |  |  |  |  |  |  |  |  |  |  |  |  |  |  |  |  |  |  |  |  |  |  |  |
| 142211845 | Installation MECH GRP - Installation cart: (2) procurement prep - Labor |  | 21d | 2013-02-14 | 2013-03-15 | 142211840 FS-31d | 95d | 0d |  | MECH ENG [40 h] | 2,894.4 | ELOUADRHIRI L | 1 | 1 | LATIFA E | Pat | 11-005 | MECH | 13-002F |  |  |  |  |  |  |  |  |  |  |  |  |  |  |  |  |  |  |  |  |  |  |  |  |  |  |  |  |
| 142211440 | BST R1-R3 HBI - 9 DAq-SCM (2) custom crate fabrication and test - Labor |  | 61d | 2013-03-06 | 2013-05-30 | 142211435 | 105d | 0d |  | ELEC ENG [80 h]; ELEC TECH [320 h] | 20,397.6 | ELOUADRHIRI L | 1 | 1 | LATIFA E | Pat | 11-005 | HBI | 13-002F | 11-058 | 12-013 |  |  |  |  |  |  |  |  |  |  |  |  |  |  |  |  |  |  |  |  |  |  |  |  |  |  |
| 142211850 | Installation MECH GRP - Installation cart: (3) construction - Proc |  | 22d | 2013-03-18 | 2013-04-16 | 142211845 | 95d | 0d |  | PROCUREMENT<$50K 60 | 15,972.26 | ELOUADRHIRI L | 1 | 1 | LATIFA E | Pat | 11-005 | MECH | 13-002F |  |  |  |  |  |  |  |  |  |  |  |  |  |  |  |  |  |  |  |  |  |  |  |  |  |  |  |  |
| 142211515 | BST R4 HBI - 5 Electronics: HFCB production modules assembly R4 - Proc |  | 17d | 2013-03-22 | 2013-04-15 | 142211510 | 37d | 0d |  | PROCUREMENT<$50K 60 | 3,057.09 | ELOUADRHIRI L | 1 | 1 | LATIFA E | Pat | 11-005 | HBI | 13-002F | 11-058 | 12-013 | 12-054F |  |  |  |  |  |  |  |  |  |  |  |  |  |  |  |  |  |  |  |  |  |  |  |  |  |
| 142211350 | BST R1-R3 MECH GRP - 3: Modules 1st article stave tests mount & aligning of modules in model of cold plate - Labor |  | 21d | 2013-03-26 | 2013-04-23 | 142211340, 142211245, 142211230, 142211320, 142211300, 142211225 FS+120d, 142211460 | 20d | 0d |  | MECH ENG [40 h]; MECH TECH [200 h] | 12,066.4 | ELOUADRHIRI L | 1 | 1 | LATIFA E | Pat | 11-005 | MECH | 13-002F | 11-058 | 12-013 | 12-054 | 12-053 |  |  |  |  |  |  |  |  |  |  |  |  |  |  |  |  |  |  |  |  |  |  |  |  |
| 142211520 | BST R4 HBI - 5 Electronics: HFCB assemble electronics for modules - Labor |  | 80d | 2013-04-16 | 2013-08-07 | 142211515 | 37d |  |  | MECH TECH [40 h] | 1,834.4 | ELOUADRHIRI L | 1 | 1 | LATIFA E | Pat | 11-005 | HBI | 13-002F | 11-058 | 12-013 | 12-054F |  |  |  |  |  |  |  |  |  |  |  |  |  |  |  |  |  |  |  |  |  |  |  |  |  |
| 142211855 | Installation MECH GRP - Installation cart: (4) construction - Labor |  | 21d | 2013-04-17 | 2013-05-15 | 142211850 | 95d |  |  | MECH TECH [80 h] | 3,668.8 | ELOUADRHIRI L | 1 | 1 | LATIFA E | Pat | 11-005 | MECH | 13-002F |  |  |  |  |  |  |  |  |  |  |  |  |  |  |  |  |  |  |  |  |  |  |  |  |  |  |  |  |
| 142211350M | End of 1st Article Program | milestone | 0d | 2013-04-23 | 2013-04-23 | 142211350 | 37d | 0d |  |  |  | ELOUADRHIRI L | 1 | 1 | LATIFA E | Pat | 11-005 | MECH | 13-002F | 11-058 | 12-013 | 12-054 |  |  |  |  |  |  |  |  |  |  |  |  |  |  |  |  |  |  |  |  |  |  |  |  |  |
| 142211465 | BST R1-R3 MECH GRP - Support, cooling, and alignment (1) of stave: manufacturing Drawings - Labor |  | 60d | 2013-04-24 | 2013-07-18 | 142211350 | 30d | 0d |  | MECH ENG [160 h]; MECH DES [320 h]; MECH TECH [80 h] | 31,153.6 | ELOUADRHIRI L | 1 | 1 | LATIFA E | Pat | 11-005 | MECH | 13-002F | 11-058 | 12-013 | 12-054 |  |  |  |  |  |  |  |  |  |  |  |  |  |  |  |  |  |  |  |  |  |  |  |  |  |
| 142211800 | Installation MECH GRP - Support and alignment tube (1) to mount solenoid, MFG Drawings (incl. alignment system) - Labor |  | 91d | 2013-04-24 | 2013-08-30 | 142211350, 9-130M FS+23d | 20d |  |  | MECH ENG [75.05 h]; MECH DES [150.1 h] | 12,892.09 | ELOUADRHIRI L | 1 | 1 | LATIFA E | Pat | 11-005 | MECH | 13-002F | 11-058 |  | 12-054 |  | 13-014 |  |  |  |  |  |  |  |  |  |  |  |  |  |  |  |  |  |  |  |  |  |  |  |
| 142211470 | BST R1-R3 MECH GRP - Support, cooling, and alignment (2) of stave: procurement prep - Labor |  | 21d | 2013-07-19 | 2013-08-16 | 142211465 | 30d |  |  | MECH ENG [40 h] | 2,894.4 | ELOUADRHIRI L | 1 | 1 | LATIFA E | Pat | 11-005 | MECH | 13-002F | 11-058 | 12-013 | 12-054 |  |  |  |  |  |  |  |  |  |  |  |  |  |  |  |  |  |  |  |  |  |  |  |  |  |
| 142211950 | Re-Baseline Actuals Adjustment |  | 1d | 2013-08-30 | 2013-08-30 | 9-130M FS+227d | 20d |  |  | PROCUREMENT>$50K 69 NO ESCALATION | -297,961.97 | ELOUADRHIRI L | 1 | 1 | LATIFA E |  |  |  |  |  |  |  |  | 13-014 | ADJ |  |  |  |  |  |  |  |  |  |  |  |  |  |  |  |  |  |  |  |  |  |  |
| 242211013E | SVT-FY13 Travel |  | 20d | 2013-09-03 | 2013-09-30 | 9-130M FS+228d | 719d | 0d | 8/5 M-F w/JLAB Holidays ReBaseline | TRAVEL | 4,502.95 | ELOUADRHIRI L | 1 | 1 | LATIFA E |  | 11-005 |  |  |  | 12-013 |  |  |  |  | 242211013E | 07-024 | E | 11-026 | 11 -035 | PE | 13-015 | PR |  |  |  |  |  |  |  |  |  |  |  |  |  |  |
| 242211130 | HBI - SVT Engineering and Construction Oversight FY13 |  | 20d | 2013-09-03 | 2013-09-30 | 9-130M FS+228d | 719d | 0d | 8/5 M-F w/JLAB Holidays ReBaseline | SCIENTIST [103.17 h] | 7,516.97 | ELOUADRHIRI L | 1 | 1 | LATIFA E | Pat | 11-005 | HBI |  |  |  |  |  |  |  | 242211130 |  | E |  |  |  | 13-015 | PR | 12-001 | PE |  |  |  |  |  |  |  |  |  |  |  |  |
| 242211160t | FNAL Construction and test (Jlab/FNAL) of R1-R3 production modules (60 modules) Part A |  | 182d | 2013-09-03 | 2014-05-30 | 242211885 FS-375d, 242211610a FS-114d, 242211890 FS-375d, 9-130M FS+228d, 242211515 FS-325d, 242211610 FS-114d, 242211520 FS-325d | 229d | 0d | 8/5 M-F w/JLAB Holidays ReBaseline | PROCUREMENT<$50K 60 NO ESCALATION | 22,828 | ELOUADRHIRI L | 1 | 1 | LATIFA E | Pat | 11-005 |  | 13-002F | 11-058 | 12-013 |  |  |  |  | 242211160t |  | D |  |  |  | 13-015 | PR |  |  | y | OB | OB |  |  |  |  |  |  |  |  |  |
| 242211160u | FNAL Construction and test (Jlab/FNAL) of R1-R3 production modules (60 modules) Part B |  | 182d | 2013-09-03 | 2014-05-30 | 242211160t FS-182d | 233.75d | 0d | 8/5 M-F w/JLAB Holidays ReBaseline | PROCUREMENT<$50K 60 NO ESCALATION; PROCUREMENT>$50K 69 NO ESCALATION | 222,139.05 | ELOUADRHIRI L | 1 | 1 | LATIFA E | Pat | 11-005 |  | 13-002F | 11-058 | 12-013 |  |  |  |  | 242211160u |  | D |  |  |  | 13-015 | PR |  |  | y | OB | OB |  |  |  |  |  |  |  |  |  |
| 242211160w | FNAL Construction and test (Jlab/FNAL) of R4 production modules Phase 1 |  | 267d | 2013-09-03 | 2014-09-30 | 242211160u FS-182d, 242211515 FS-325d, 242211520 FS-325d | 262d | 33d | 8/5 M-F w/JLAB Holidays ReBaseline | PROCUREMENT>$50K 69 NO ESCALATION FY14 | 46,506.36 | ELOUADRHIRI L | 1 | 1 | LATIFA E | Pat | 11-005 |  | 13-002F | 11-058 | 12-013 |  |  |  |  | 242211160w |  | D |  |  |  | 13-015 | PR |  |  | y | OB | OB |  |  |  |  |  |  |  |  |  |
| 242211160w5 | FNAL Construction and test (Jlab/FNAL) of R4 production modules Phase 2 |  | 267d | 2013-09-03 | 2014-09-30 | 242211515 FS-325d, 242211520 FS-325d, 242211160u FS-182d | 262d | 33d | 8/5 M-F w/JLAB Holidays ReBaseline | PROCUREMENT>$50K 69 NO ESCALATION FY14 | 63,581.94 | ELOUADRHIRI L | 1 | 1 | LATIFA E | Pat | 11-005 |  | 13-002F | 11-058 | 12-013 |  |  |  |  | 242211160w |  | D |  |  |  | 13-015 | PR |  |  |  | OB |  |  |  |  |  |  |  |  |  |  |
| 242211335 | MECH GRP - Modules: asssembly table, mounting, and alignment fixture procurement - Proc |  | 9d | 2013-09-03 | 2013-09-13 | 9-130M FS+228d | 255d | 0d | 8/5 M-F w/JLAB Holidays ReBaseline | PROCUREMENT<$50K 60 | 1,289.7 | ELOUADRHIRI L | 1 | 1 | LATIFA E | Pat | 11-005 | MECH | 13-002F | 11-058 | 12-013 | 12-054F |  |  |  | 242211335 |  | D |  |  |  | 13-015 | PR |  |  |  | CP |  | 12-027 |  |  |  |  |  |  |  |  |
| 242211360 | HBI - Electronics HFCB R1-R4 - Proc |  | 139d | 2013-09-03 | 2014-03-31 | 9-130M FS+228d | 329d | 0d | 8/5 M-F w/JLAB Holidays ReBaseline | PROCUREMENT<$50K 60 NO ESCALATION FY14; PROCUREMENT>$50K 69 NO ESCALATION FY14 | 101,920 | ELOUADRHIRI L | 1 | 1 | LATIFA E | Pat | 11-005 | HBI | 13-002F | 11-058 | 12-013 | 12-054F |  |  |  | 242211360 |  | U |  |  |  | 13-015 | PR |  |  | y | OB | OB |  |  |  |  |  |  |  |  |  |
| 242211361 | HBI - Electronics HFCB R1-R4 - Proc First Article 6 cables |  | 14d | 2013-09-03 | 2013-09-20 | 9-130M FS+228d | 527d | 0d | 8/5 M-F w/JLAB Holidays ReBaseline | PROCUREMENT<$50K 60 NO ESCALATION | 7,350 | ELOUADRHIRI L | 1 | 1 | LATIFA E | Pat | 11-005 | HBI | 13-002F | 11-058 | 12-013 | 12-054F |  |  |  | 242211361 |  | U |  |  |  | 13-015 | PR |  |  | y | OB | OB |  | 6000 | 0 | 0 | 100 |  |  |  |  |
| 242211365a | HBI - Cable assemblies: HV, LV, and data - Proc |  | 98d | 2013-09-03 | 2014-01-31 | 9-130M FS+228d | 322.75d | 73.75d | 8/5 M-F w/JLAB Holidays ReBaseline | PROCUREMENT<$50K 60 NO ESCALATION; PROCUREMENT>$50K 69 NO ESCALATION | 80,925 | ELOUADRHIRI L | 1 | 1 | LATIFA E | Pat | 11-005 | HBI | 13-002F |  | 12-013 |  |  |  |  | 242211365a |  | U |  |  |  | 13-015 | PR |  |  | y | OB | OB |  |  |  |  |  | 12-055 |  |  |  |
| 242211367 | HBI - Cable assemblies: Pulser |  | 139d | 2013-09-03 | 2014-03-31 | 9-130M FS+228d | 281.75d | 32.75d | 8/5 M-F w/JLAB Holidays ReBaseline | PROCUREMENT<$50K 60 NO ESCALATION FY14 | 19,640.4 | ELOUADRHIRI L | 1 | 1 | LATIFA E | Pat | 11-005 | HBI | 13-002F |  | 12-013 |  |  |  |  | 242211367 |  | U |  |  |  | 13-015 | PR |  |  | y | OB | OB |  |  |  |  |  | 12-055 |  |  |  |
| 242211370 | HBI - Cable assemblies: HV, LV, and data fabrication and testing R1-R4 - Labor FY13 |  | 20d | 2013-09-03 | 2013-09-30 | 9-130M FS+228d | 249d | 0d | 8/5 M-F w/JLAB Holidays ReBaseline | ELEC TECH [21.98 h] | 1,000.97 | ELOUADRHIRI L | 1 | 1 | LATIFA E | Pat | 11-005 | HBI | 13-002F |  | 12-013 |  |  |  |  | 242211370 |  | S |  |  |  | 13-015 | PR |  | PE |  |  |  |  |  |  |  |  |  | ST |  |  |
| 242211405a | Obligated Procured Labor for Activity 242211405 |  | 99d | 2013-09-03 | 2014-02-03 | 9-130M FS+228d | 299d | 0d | 8/5 M-F w/JLAB Holidays ReBaseline | PROCUREMENT>$50K 69 NO ESCALATION FY14 | 1,792 | ELOUADRHIRI L | 1 | 1 | LATIFA E | Pat | 11-005 | MECH | 13-002F |  |  | 12-054F |  |  |  | 242211405 |  | S |  |  | PE | 13-015 | PR |  | PE | y |  | OB | 12-027F |  |  |  |  |  | ST |  |  |
| 242211410 | MECH GRP - Faraday cage protective enclosure system specifications and procurement prep - Labor FY13 |  | 20d | 2013-09-03 | 2013-09-30 | 242211405a FS-99d, 242211405 FS-99d | 299d | 0d | 8/5 M-F w/JLAB Holidays ReBaseline | MECH ENG [1.5 h] | 108.54 | ELOUADRHIRI L | 1 | 1 | LATIFA E | Pat | 11-005 | MECH | 13-002F |  |  | 12-054F |  |  |  | 242211410 |  | H |  |  |  | 13-015 | PR |  | PE |  |  |  | 12-027F |  |  |  |  |  |  |  |  |
| 242211465 | MECH GRP - Support, cooling, coldplate, and alignment of stave: manufacturing Drawings - Labor |  | 14d | 2013-09-03 | 2013-09-20 | 9-130M FS+228d | 255d | 0d | 8/5 M-F w/JLAB Holidays ReBaseline | PLABOR; MECH ENG [20 h] | 5,927.2 | ELOUADRHIRI L | 1 | 1 | LATIFA E | Pat | 11-005 | MECH | 13-002F | 11-058 | 12-013 | 12-054 |  |  |  | 242211465 |  | S |  |  | PE | 13-015 | PR |  | PE |  |  |  |  |  |  |  |  |  |  | 5927.2 |  |
| 242211490 | HBI - Module R1-R4 : quality assurance, test, and burn-in at FNAL - Labor FY13 |  | 20d | 2013-09-03 | 2013-09-30 | 242211160w FS-300d, 242211160u FS-186.75d, 242211160t FS-182d, 242211160w5 FS-300d | 229d | 0d | 8/5 M-F w/JLAB Holidays ReBaseline | ELEC ENG [66.67 h]; ELEC TECH [66.67 h]; VISTNG USERS [134.83 h] | 10,579.7 | ELOUADRHIRI L | 1 | 1 | LATIFA E | Pat | 11-005 | HBI | 13-002F | 11-058 |  | 12-054 |  |  |  | 242211490 |  | U |  |  |  | 13-015 | PR |  | PE |  |  |  |  |  |  |  |  |  |  |  |  |
| 242211515 | HBI - Electronics: HFCB assembly - Proc Part A |  | 161d | 2013-09-03 | 2014-04-30 | 242211360 FS-139d | 393d | 164d | 8/5 M-F w/JLAB Holidays ReBaseline | PROCUREMENT<$50K 60 NO ESCALATION FY14 | 24,520.2 | ELOUADRHIRI L | 1 | 1 | LATIFA E | Pat | 11-005 | HBI | 13-002F | 11-058 | 12-013 | 12-054F |  |  |  | 242211515 |  | U |  |  |  | 13-015 | PR |  |  | y | VQ | OB |  |  |  |  |  |  |  |  |  |
| 242211530 | HBI - Compunetics HFCB Bend Test - Proc |  | 20d | 2013-09-03 | 2013-09-30 | 9-130M FS+228d, 242211361 FS-14d | 527d | 298d | 8/5 M-F w/JLAB Holidays ReBaseline | PROCUREMENT<$50K 60 | 200 | ELOUADRHIRI L | 1 | 1 | LATIFA E | Pat | 11-005 | HBI | 13-002F | 11-058 | 12-013 | 12-054F |  |  |  | 242211530 |  | D |  |  |  | 13-015 | PR |  |  | y | OB | OB |  |  |  |  |  |  |  |  |  |
| 242211605 | HBI - Bus cable PCB production - Proc |  | 62d | 2013-09-03 | 2013-11-27 | 9-130M FS+228d | 266d | 0d | 8/5 M-F w/JLAB Holidays ReBaseline | PROCUREMENT<$50K 60 NO ESCALATION FY14 | 22,550 | ELOUADRHIRI L | 1 | 1 | LATIFA E | Pat | 11-005 | MECH | 13-002F | 11-058 |  | 12-054 |  |  |  | 242211605 |  | D |  |  |  | 13-015 | PR |  |  | y | OB | OB |  |  |  |  |  |  |  |  |  |
| 242211620 | FNAL Tooling |  | 20d | 2013-09-03 | 2013-09-30 | 9-130M FS+228d | 551d | 548d | 8/5 M-F w/JLAB Holidays ReBaseline | PROCUREMENT<$50K 60 | 6,259.1 | ELOUADRHIRI L | 1 | 1 | LATIFA E | Pat | 11-005 | MECH | 13-002F | 11-058 |  | 12-054 |  |  |  | 242211605 |  | D |  |  |  | 13-015 | PR |  |  | y | OB | OB |  |  |  |  |  |  |  |  |  |
| 242211670 | INFRA STR - Integrated Humidity Reduction System for SVT Control room - Proc |  | 43d | 2013-09-03 | 2013-10-31 | 9-130M FS+228d | 453d | 224d | 8/5 M-F w/JLAB Holidays ReBaseline | PROCUREMENT<$50K 60 NO ESCALATION FY14 | 4,661.78 | ELOUADRHIRI L | 1 | 1 | LATIFA E | Pat | 11-005 | MECH | 13-002F | 11-058 |  | 12-054 |  |  |  | 242211670 |  | D |  |  |  | 13-015 | PR |  |  | y | PE | OB |  |  |  |  |  |  |  |  |  |
| 242211705 | MECH GRP - Tooling for assembly and repairs: manufacturing Drawings - Labor/Expenses FY13 |  | 20d | 2013-09-03 | 2013-09-30 | 9-130M FS+228d | 256.5d | 0d | 8/5 M-F w/JLAB Holidays ReBaseline | PLABOR; MECH ENG [12.9 h] | 3,245.7 | ELOUADRHIRI L | 1 | 1 | LATIFA E | Pat | 11-005 | MECH | 13-002F | 11-058 |  | 12-054 |  |  |  | 242211705 |  | H |  |  | PE | 13-015 | PR |  | PE |  |  |  |  |  |  |  |  |  |  |  |  |
| 242211710 | MECH GRP - Tooling for assembly and repairs: procurement prep - Labor FY13 |  | 20d | 2013-09-03 | 2013-09-30 | 242211705 FS-31d, 242211705a FS-31d | 256.5d | 0d | 8/5 M-F w/JLAB Holidays ReBaseline | PLABOR; MECH ENG [3.72 h] | 269.18 | ELOUADRHIRI L | 1 | 1 | LATIFA E | Pat | 11-005 | MECH | 13-002F | 11-058 |  | 12-054 |  |  |  | 242211710 |  | H |  |  |  | 13-015 | PR |  | PE |  |  |  |  |  |  |  |  |  |  |  |  |
| 242211755 | HBI - Additional HFCB - Proc |  | 139d | 2013-09-03 | 2014-03-31 | 9-130M FS+228d | 408d | 179d | 8/5 M-F w/JLAB Holidays ReBaseline | PROCUREMENT<$50K 60 NO ESCALATION FY14 | 39,100 | ELOUADRHIRI L | 1 | 1 | LATIFA E | Pat | 11-005 | MECH | 13-002F | 11-058 |  | 12-054 |  |  |  | 242211755 |  | D |  |  |  | 13-015 | PR |  |  | y | PE | OB |  |  |  |  |  |  |  |  |  |
| 242211715 | MECH GRP - Tooling for assembly and repairs - Proc |  | 62d | 2013-09-03 | 2013-12-02 | 242211710 FS-43d, 242211710a FS-43d | 256.5d | 0d | 8/5 M-F w/JLAB Holidays ReBaseline | SUPPLIES & MATERIALS; PROCUREMENT<$50K 60 NO ESCALATION FY14 | 8,308.5 | ELOUADRHIRI L | 1 | 1 | LATIFA E | Pat | 11-005 | MECH | 13-002F | 11-058 |  | 12-054 |  |  |  | 242211715 |  | D |  |  |  | 13-015 | PR |  |  |  | EJ |  |  |  |  |  |  |  |  |  |  |
| 242211610 | HBI - Bus cable PCB receive and Test - Labor FY13 |  | 18d | 2013-09-05 | 2013-09-30 | 242211605 FS-60d | 266d | 0d | 8/5 M-F w/JLAB Holidays ReBaseline | ELEC TECH [9.6 h] | 437.18 | ELOUADRHIRI L | 1 | 1 | LATIFA E | Pat | 11-005 | MECH | 13-002F | 11-058 |  | 12-054 |  |  |  | 242211610 |  | H |  |  |  | 13-015 | PR |  | PE |  |  |  |  |  |  |  |  |  |  |  |  |
| 242211470 | MECH GRP - Support, cooling, coldplate, and alignment of stave: procurement prep - Labor |  | 6d | 2013-09-23 | 2013-09-30 | 242211465 | 255d | 0d | 8/5 M-F w/JLAB Holidays ReBaseline | MECH ENG [8 h] | 578.88 | ELOUADRHIRI L | 1 | 1 | LATIFA E | Pat | 11-005 | MECH | 13-002F | 11-058 | 12-013 | 12-054 |  |  |  | 242211470 |  | H |  |  |  | 13-015 | PR |  | PE |  |  |  |  |  |  |  |  |  |  |  |  |
| 242211014E | SVT-FY14 Travel |  | 247d | 2013-10-01 | 2014-09-30 | 242211013E | 719d | 0d | 8/5 M-F w/JLAB Holidays ReBaseline | TRAVEL | 34,259.08 | ELOUADRHIRI L | 1 | 1 | LATIFA E |  | 11-005 |  |  |  | 12-013 |  |  |  |  | 242211014E | 07-024 | E | 11-026 | 11 -035 | PE | 13-015 | PR |  |  |  |  |  |  |  |  |  |  |  |  |  | 14-001 |
| 242211140 | HBI - SVT Engineering and Construction Oversight FY14 |  | 247d | 2013-10-01 | 2014-09-30 | 242211130 | 719d | 0d | 8/5 M-F w/JLAB Holidays ReBaseline | SCIENTIST [949.6 h] | 71,390.93 | ELOUADRHIRI L | 1 | 1 | LATIFA E | Pat | 11-005 | HBI |  |  |  |  |  |  |  | 242211140 |  | E |  |  |  | 13-015 | PR | 12-001 | PE |  |  |  |  |  |  |  |  |  |  |  | 14-001 |
| 242211370a | HBI - Cable assemblies: HV, LV, and data fabrication and testing R1-R4 - Labor FY14 |  | 162d | 2013-10-01 | 2014-05-30 | 9-130M FS+228d, 242211370 | 249d | 0d | 8/5 M-F w/JLAB Holidays ReBaseline | ELEC TECH [178.02 h] | 8,365.16 | ELOUADRHIRI L | 1 | 1 | LATIFA E | Pat | 11-005 | HBI | 13-002F |  | 12-013 |  |  |  |  | 242211370 |  | S |  |  |  | 13-015 | PR |  | PE |  |  |  |  |  |  |  |  |  | ST |  | 14-001 |
| 242211390 | HBI - Sloco: Slow controls for monitoring and charge calibration system: component procurement - Proc |  | 57d | 2013-10-01 | 2013-12-20 | 9-140M | 377d | 0d | 8/5 M-F w/JLAB Holidays ReBaseline | PROCUREMENT<$50K 60 | 67,644.14 | ELOUADRHIRI L | 1 | 1 | LATIFA E | Pat | 11-005 | HBI | 13-002F | 11-058 |  | 12-054 |  |  |  | 242211390 |  | D |  |  |  | 13-015 | PR |  |  |  | PE |  | 12-027 |  |  |  |  |  |  |  | 14-001 |
| 242211405 | MECH GRP - Faraday cage protective enclosure system Manufacturing Drawings - Labor |  | 79d | 2013-10-01 | 2014-02-03 | 9-140M | 299d | 0d | 8/5 M-F w/JLAB Holidays ReBaseline | PLABOR; MECH ENG [40 h] | 3,911.38 | ELOUADRHIRI L | 1 | 1 | LATIFA E | Pat | 11-005 | MECH | 13-002F |  |  | 12-054F |  |  |  | 242211405 |  | S |  |  | PE | 13-015 | PR |  | PE |  |  |  | 12-027F |  |  |  |  |  | ST |  | 14-001 |
| 242211410a | MECH GRP - Faraday cage protective enclosure system specifications and procurement prep - Labor FY14 |  | 87d | 2013-10-01 | 2014-02-13 | 242211405a FS-99d, 242211405 FS-99d, 242211410 | 299d | 0d | 8/5 M-F w/JLAB Holidays ReBaseline | MECH ENG [6.5 h] | 485.36 | ELOUADRHIRI L | 1 | 1 | LATIFA E | Pat | 11-005 | MECH | 13-002F |  |  | 12-054F |  |  |  | 242211410 |  | H |  |  |  | 13-015 | PR |  | PE |  |  |  | 12-027F |  |  |  |  |  |  |  | 14-001 |
| 242211475 | MECH GRP - Support, cooling, coldplate, and alignment of stave - Proc |  | 23d | 2013-10-01 | 2013-10-31 | 242211470 | 255d | 0d | 8/5 M-F w/JLAB Holidays ReBaseline | PROCUREMENT<$50K 60 | 26,128.74 | ELOUADRHIRI L | 1 | 1 | LATIFA E | Pat | 11-005 | MECH | 13-002F | 11-058 | 12-013 | 12-054 |  |  |  | 242211475 |  | D |  |  |  | 13-015 | PR |  |  |  | EJ |  |  |  |  |  |  |  |  |  | 14-001 |
| 242211490a | HBI - Module R1-R4 : quality assurance, test, and burn-in at FNAL - Labor FY14 |  | 247d | 2013-10-01 | 2014-09-30 | 242211160w5 FS-300d, 242211490, 242211160w FS-300d, 242211160u FS-186.75d, 242211160t FS-182d | 229d | 0d | 8/5 M-F w/JLAB Holidays ReBaseline | ELEC ENG [823.33 h]; ELEC TECH [823.33 h]; VISTNG USERS [1665.17 h] | 134,831.48 | ELOUADRHIRI L | 1 | 1 | LATIFA E | Pat | 11-005 | HBI | 13-002F | 11-058 |  | 12-054 |  |  |  | 242211490 |  | U |  |  |  | 13-015 | PR |  | PE |  |  |  |  |  |  |  |  |  |  |  | 14-001 |
| 242211610a | HBI - Bus cable PCB receive and Test - Labor FY14 |  | 57d | 2013-10-01 | 2013-12-20 | 242211610, 242211605 FS-60d | 266d | 37d | 8/5 M-F w/JLAB Holidays ReBaseline | ELEC TECH [30.4 h] | 1,428.5 | ELOUADRHIRI L | 1 | 1 | LATIFA E | Pat | 11-005 | MECH | 13-002F | 11-058 |  | 12-054 |  |  |  | 242211610 |  | H |  |  |  | 13-015 | PR |  | PE |  |  |  |  |  |  |  |  |  |  |  | 14-001 |
| 242211635 | HBI - LV cards - Proc |  | 119d | 2013-10-01 | 2014-03-31 | 9-140M | 357d | 128d | 8/5 M-F w/JLAB Holidays ReBaseline | PROCUREMENT<$50K 60 | 50,583.74 | ELOUADRHIRI L | 1 | 1 | LATIFA E | Pat | 11-005 | MECH | 13-002F | 11-058 |  | 12-054 |  |  |  | 242211635 |  | D |  |  |  | 13-015 | PR |  |  |  | PE |  |  |  |  |  |  |  |  |  | 14-001 |
| 242211655 | HBI - VXS crate - Proc |  | 119d | 2013-10-01 | 2014-03-31 | 9-140M | 357d | 128d | 8/5 M-F w/JLAB Holidays ReBaseline | PROCUREMENT<$50K 60 | 11,347.8 | ELOUADRHIRI L | 1 | 1 | LATIFA E | Pat | 11-005 | MECH | 13-002F | 11-058 |  | 12-054 |  |  |  | 242211655 |  | U |  |  |  | 13-015 | PR |  |  |  | PE |  |  |  |  |  |  |  |  |  | 14-001 |
| 242211705a | MECH GRP - Tooling for assembly and repairs: manufacturing Drawings - Labor/Expenses FY14 |  | 11d | 2013-10-01 | 2013-10-15 | 9-130M FS+228d, 242211705 | 256.5d | 0d | 8/5 M-F w/JLAB Holidays ReBaseline | PLABOR; MECH ENG [7.1 h] | 1,842.47 | ELOUADRHIRI L | 1 | 1 | LATIFA E | Pat | 11-005 | MECH | 13-002F | 11-058 |  | 12-054 |  |  |  | 242211705 |  | H |  |  | PE | 13-015 | PR |  | PE |  |  |  |  |  |  |  |  |  |  |  | 14-001 |
| 242211710a | MECH GRP - Tooling for assembly and repairs: procurement prep - Labor FY14 |  | 23.5d | 2013-10-01 | 2013-11-01 | 242211705 FS-31d, 242211705a FS-31d, 242211710 | 256.5d | 0d | 8/5 M-F w/JLAB Holidays ReBaseline | PLABOR; MECH ENG [4.28 h] | 319.59 | ELOUADRHIRI L | 1 | 1 | LATIFA E | Pat | 11-005 | MECH | 13-002F | 11-058 |  | 12-054 |  |  |  | 242211710 |  | H |  |  |  | 13-015 | PR |  | PE |  |  |  |  |  |  |  |  |  |  |  | 14-001 |
| 242211875 | MECH GRP - Construct silicon module shipping containers -Proc Part A |  | 98d | 2013-10-01 | 2014-02-28 | 9-140M | 347d | 114d | 8/5 M-F w/JLAB Holidays ReBaseline | PROCUREMENT<$50K 60 | 21,892.79 | ELOUADRHIRI L | 1 | 1 | LATIFA E | Pat | 11-005 | MECH | 13-002F |  |  |  |  |  |  | 242211875 |  | D |  |  |  | 13-015 | PR |  |  |  | PE |  |  |  |  |  |  |  |  |  | 14-001 |
| 242211885 | MECH GRP - Module inserts Copper/PEEK Part A |  | 54d | 2013-10-01 | 2013-12-17 | 9-140M | 530d | 301d | 8/5 M-F w/JLAB Holidays ReBaseline | PROCUREMENT<$50K 60 | 2,734.54 | ELOUADRHIRI L | 1 | 1 | LATIFA E | Pat | 11-005 | MECH | 13-002F |  |  |  |  |  |  | 242211885 |  | D |  |  |  | 13-015 | PR |  |  |  | PE |  |  |  |  |  |  |  |  |  | 14-001 |
| 242211340 | MECH GRP - Modules: assembly table, mounting, and alignment fixture construction - Labor |  | 20d | 2013-10-04 | 2013-10-31 | 242211335 FS+14d | 255d | 0d | 8/5 M-F w/JLAB Holidays ReBaseline | MECH TECH [40 h] | 1,892.8 | ELOUADRHIRI L | 1 | 1 | LATIFA E | Pat | 11-005 | MECH | 13-002F | 11-058 | 12-013 | 12-054F |  |  |  | 242211340 |  | H |  |  |  | 13-015 | PR |  | PE |  |  |  | 12-027 |  |  |  |  |  |  |  | 14-001 |
| 242211460 | MECH GRP - Cooling system: procurement - proc |  | 31d | 2013-10-04 | 2013-11-15 | 9-140M FS+3d | 255d | 0d | 8/5 M-F w/JLAB Holidays ReBaseline | PROCUREMENT<$50K 60 | 8,158.2 | ELOUADRHIRI L | 1 | 1 | LATIFA E | Pat | 11-005 | MECH | 13-002F | 11-058 | 12-013 | 12-054F |  |  |  | 242211460 |  | D |  |  |  | 13-015 | PR |  |  |  | CP |  |  |  |  |  |  |  |  |  | 14-001 |
| 242211685 | MECH GRP - Region 4 Support, cooling, coldplate, and alignment structure: manufacturing Drawings - Labor |  | 68d | 2013-10-15 | 2014-01-31 | 9-140M FS+10d | 269d | 0d | 8/5 M-F w/JLAB Holidays ReBaseline | MECH ENG [80 h]; PLABOR; MECH TECH [40 h] | 18,961.39 | ELOUADRHIRI L | 1 | 1 | LATIFA E | Pat | 11-005 | MECH | 13-002F | 11-058 |  | 12-054 |  |  |  | 242211685 |  | S |  |  | PE | 13-015 | PR |  | PE |  |  |  |  |  |  |  |  |  | ST |  | 14-001 |
| 242211445 | HBI - DAq-VSCM develop program and test - Labor |  | 98d | 2013-10-17 | 2014-03-18 | 9-140M FS+12d | 249d | 0d | 8/5 M-F w/JLAB Holidays ReBaseline | ELEC ENG [240 h] | 18,031.2 | ELOUADRHIRI L | 1 | 1 | LATIFA E | Pat | 11-005 | HBI | 13-002F | 11-058 | 12-013 |  |  |  |  | 242211445 |  | S |  |  |  | 13-015 | PR |  | PE |  |  |  |  |  |  |  |  |  | ST |  | 14-001 |
| 242211380 | HBI - Sloco: HV, LV, PS distribution system (fabricate) - Labor |  | 11d | 2013-11-01 | 2013-11-15 | 9-140M FS+23d | 255d | 0d | 8/5 M-F w/JLAB Holidays ReBaseline | ELEC TECH [30 h] | 1,409.7 | ELOUADRHIRI L | 1 | 1 | LATIFA E | Pat | 11-005 | HBI | 13-002F |  | 12-013 |  |  |  |  | 242211380 |  | H |  |  |  | 13-015 | PR |  | PE |  |  |  |  |  |  |  |  |  |  |  | 14-001 |
| 242211480 | MECH GRP - Support, cooling, coldplate, and alignment of stave Faraday Cage inner: construct and assemble - Labor |  | 11d | 2013-11-01 | 2013-11-15 | 242211415 FS-120d, 242211475, 242211340 | 255d | 0d | 8/5 M-F w/JLAB Holidays ReBaseline | PLABOR; MECH ENG [40 h]; MECH TECH [240 h] | 16,192.76 | ELOUADRHIRI L | 1 | 1 | LATIFA E | Pat | 11-005 | MECH | 13-002F | 11-058 | 12-013 | 12-054 |  |  |  | 242211480 |  | S |  |  | PE | 13-015 | PR |  | PE |  |  |  |  |  |  |  |  |  | ST |  | 14-001 |
| 242211725 | MECH GRP - Tooling for dissassembly, and repairs : manufacturing Drawings - Labor |  | 75d | 2013-11-01 | 2014-02-28 | 9-140M FS+23d | 355d | 0d | 8/5 M-F w/JLAB Holidays ReBaseline | PLABOR; MECH ENG [80 h] | 18,917.75 | ELOUADRHIRI L | 1 | 1 | LATIFA E | Pat | 11-005 | MECH | 13-002F | 11-058 |  | 12-054 |  |  |  | 242211725 |  | S |  |  | PE | 13-015 | PR |  | PE |  |  |  |  |  |  |  |  |  | ST |  | 14-001 |
| 242211485 | MECH GRP - Mounting and aligning on support structure in lab, R1-R3 - Labor |  | 118d | 2013-11-18 | 2014-05-15 | 242211645 FS-250d, 242211460, 242211480, 242211720 FS-25d, 242211380, 242211415 FS-140d | 255d | 6d | 8/5 M-F w/JLAB Holidays ReBaseline | PLABOR; MECH ENG [40 h]; MECH TECH [480 h] | 27,549.56 | ELOUADRHIRI L | 1 | 1 | LATIFA E | Pat | 11-005 | MECH | 13-002F | 11-058 |  | 12-054 |  |  |  | 242211485 |  | S |  |  | PE | 13-015 | PR |  | PE |  |  |  |  |  |  |  |  |  | ST |  | 14-001 |
| 242211876 | MECH GRP - Module shipping Charges from FNAL to Jlab - Proc |  | 216d | 2013-12-02 | 2014-10-15 | 242211875a FS-170d, 9-140M FS+42d, 242211875 FS-170d | 233d | 4d | 8/5 M-F w/JLAB Holidays ReBaseline | PROCUREMENT<$50K 60 NO ESCALATION FY15 | 13,414.7 | ELOUADRHIRI L | 1 | 1 | LATIFA E | Pat | 11-005 | MECH | 13-002F |  |  |  |  |  |  | 242211876 |  | D |  |  |  | 13-015 | PR |  |  |  | EV |  |  |  |  |  |  |  |  |  | 14-001 |
| 242211720 | MECH GRP - Tooling for assembly and repairs construct and assemble - Labor |  | 15d | 2013-12-02 | 2014-01-02 | 242211715 | 256.5d | 1.5d | 8/5 M-F w/JLAB Holidays ReBaseline | PLABOR; MECH ENG [40 h]; MECH TECH [160 h] | 14,256.33 | ELOUADRHIRI L | 1 | 1 | LATIFA E | Pat | 11-005 | MECH | 13-002F | 11-058 |  | 12-054 |  |  |  | 242211720 |  | S |  |  | PE | 13-015 | PR |  | PE |  |  |  |  |  |  |  |  |  | ST |  | 14-001 |
| 242211520 | HBI - Electronics: HFCB assembly - Proc Part B |  | 161d | 2013-12-04 | 2014-07-31 | 242211360 FS-75d | 329d | 100d | 8/5 M-F w/JLAB Holidays ReBaseline | PROCUREMENT<$50K 60 | 34,620.04 | ELOUADRHIRI L | 1 | 1 | LATIFA E | Pat | 11-005 | HBI | 13-002F | 11-058 | 12-013 | 12-054F |  |  |  | 242211515 |  | U |  |  |  | 13-015 | PR |  |  |  | VQ |  |  |  |  |  |  |  |  |  | 14-001 |
| 242211645 | HBI - Module Reception tests at JLAB - Labor |  | 223d | 2013-12-09 | 2014-10-31 | 242211490a FS-200d, 242211490 FS-200d | 269d | 14d | 8/5 M-F w/JLAB Holidays ReBaseline | ELEC TECH [400 h]; ELEC ENG [200 h] | 33,822 | ELOUADRHIRI L | 1 | 1 | LATIFA E | Pat | 11-005 | MECH | 13-002F | 11-058 |  | 12-054 |  |  |  | 242211645 |  | U |  |  |  | 13-015 | PR |  | PE |  |  |  |  |  |  |  |  |  |  |  | 14-001 |
| 242211615 | HBI - Full system R1-R3, test and burn-in in Cleanroom EEL 121 - Labor |  | 115d | 2013-12-10 | 2014-06-02 | 242211485 FS-110d, 242211370 FS-114d, 242211365a FS-103.75d, 242211445 FS-62d, 242211367 FS-103.75d, 242211370a FS-114d | 249d | 0d | 8/5 M-F w/JLAB Holidays ReBaseline | ELEC TECH [180 h]; ELEC ENG [180 h]; VISTNG USERS [1280 h] | 48,336.8 | ELOUADRHIRI L | 1 | 1 | LATIFA E | Pat | 11-005 | MECH | 13-002F | 11-058 |  | 12-054 |  |  |  | 242211615 |  | S |  |  |  | 13-015 | PR |  | PE |  |  |  |  |  |  |  |  |  | ST |  | 14-001 |
| 242211395 | HBI - Sloco:Slow controls for monitoring and charge calib system: assemble, test, and debug ADC's- Labor |  | 42d | 2014-01-02 | 2014-03-03 | 242211390 | 377d | 148d | 8/5 M-F w/JLAB Holidays ReBaseline | ELEC ENG [160 h]; ELEC TECH [160 h] | 19,539.2 | ELOUADRHIRI L | 1 | 1 | LATIFA E | Pat | 11-005 | HBI | 13-002F | 11-058 |  | 12-054 | 12-053 |  |  | 242211395 |  | S |  |  |  | 13-015 | PR |  | PE |  |  |  | 12-027 |  |  |  |  |  | ST |  | 14-001 |

Notes:
- 142211515: Explanation: total PCB assembly
- 242211360: Explanation: HFCB boards (63 @ $625) $39,375, setup $1400, electrical test / $650, connector head (126 @ $3.2578) $410.48, SMT conn. 37 pin (63 @ / $122.10) $7962.30, SMT conn. 51 pin (63 @ $180.54) $11,374.02, / additional board parts (63 @ $21.67) $1365.21
- 242211361: Explanation: HFCB boards (63 @ $625) $39,375, setup $1400, electrical test / $650, connector head (126 @ $3.2578) $410.48, SMT conn. 37 pin (63 @ / $122.10) $7962.30, SMT conn. 51 pin (63 @ $180.54) $11,374.02, / additional board parts (63 @ $21.67) $1365.21
- 242211365a: Explanation: cable (1000') $2821.55, cable (1000') $795.73, connectors / (1400 @ 0.0773) $108.26, connectors single row (212 @ 0.526) $111.51, straight / plug conncetor 37 pin (106 @ 124.13) $13,157.78, straight plug / conncetor 51 pin (106 @ 181.36) $19224.16
- 242211367: Explanation: cable (1000') $2821.55, cable (1000') $795.73, connectors / (1400 @ 0.0773) $108.26, connectors single row (212 @ 0.526) $111.51, straight / plug conncetor 37 pin (106 @ 124.13) $13,157.78, straight plug / conncetor 51 pin (106 @ 181.36) $19224.16
- 242211370: Steps: Manufacture HV, LV, pulser, ground reference, and slow control cables; Test HV, LV, pulser, ground reference, slow control cables, and data cables
- 242211405a: Steps: Completion of CAD model; Completion of drawings; Drawings review and release
- 242211515: Explanation: total PCB assembly
- 242211530: Explanation: total PCB assembly
- 242211370a: Steps: Manufacture HV, LV, pulser, ground reference, and slow control cables; Test HV, LV, pulser, ground reference, slow control cables, and data cables
- 242211390: Explanation: analog module $511.97, input module $511.97, 8-slot / backplane $608.75, LabVIEW real-time/Ethernet controller $1837.85, NI standard / system assurance program $250, PS-4 power supply $240.98, connector block (2 @ / 163.56) $327.12, LabVIEW real-time module $2515.31, optical module / $24,765
- 242211405: Steps: Completion of CAD model; Completion of drawings; Drawings review and release
- 242211685: Steps: Completion of CAD model; Completion of drawings; Drawings review and release
- 242211445: Steps: Test multiple VSCM cards in VXS crates; Test clock distribution via SD cards; Test TI cards with multiple crates; Test SVT TI with master trigger; Integrate with CODA
- 242211480: Steps: Inspection of parts; Assembly of parts
- 242211725: Steps: Completion of CAD model; Completion of drawings; Drawings review and release
- 242211485: Steps: Assembly set-up and install inner shell; Assemble Region 1; Assemble Region 2; Assemble Region 3
- 242211720: Steps: Check parts for transition fixture; Assemble transition fixture; Check parts for transition cart; Assemble transition cart
- 242211520: Explanation: total PCB assembly
- 242211615: Steps: Checkout of Front-End electronics; Checkout of the High-Voltage system and distribution; Checkout of the Low-Voltage System; Checkout of DAQ and Trigger; Checkout of gas system; Checkout of safety system (interlock LV/HV/cooling/gas
- 242211395: Steps: Test and calibrate individual monitoring sensors (e.g. temperature sensor); Assemble tested sensors in the silicon detector barrel; Debug system? hardware

| ID | Activity | Type | Duration | Start | Finish | Predecessors | Total float | Free float | Calendar | Resources | Cost | Original Activity ID Rebaseline | RESP - Responsibility | STRT%COMP for CM EVM | FNSH%COMP for CM EVM | EVMS Reporting Codes | CAM RESPONSIBLE | Activities with Steps | Pat's Code | CR 11-005 | SVT | CR 11-058 | CR 12-027 | CR 12-053 | CR 12-054 | CR 13-002 | BOE Labor | CR 13-015 | Post Rebaseline | CR 14-001 | BOE Procurement | BOE Expenses | CR 12-001 |
| --- | --- | --- | --- | --- | --- | --- | --- | --- | --- | --- | --- | --- | --- | --- | --- | --- | --- | --- | --- | --- | --- | --- | --- | --- | --- | --- | --- | --- | --- | --- | --- | --- | --- |
| 242211400a | HBI - Sloco:Slow controls for monitor and charge calib system: develop sloco software (1/2) - Labor |  | 109d | 2014-01-07 | 2014-06-10 | 9-140M FS+60d | 307d | 78d | 8/5 M-F w/JLAB Holidays ReBaseline | ELEC ENG [160 h]; ELEC TECH [360 h] | 28,937.2 | 242211400a | ELOUADRHIRI L | 1 | 1 | S | LATIFA E | ST | Pat | 11-005 | HBI | 11-058 | 12-027 | 12-053 | 12-054F | 13-002F | PE | 13-015 | PR | 14-001 |  |  |  |
| 242211890 | MECH GRP - Module inserts Copper/PEEK Part B |  | 54d | 2014-01-07 | 2014-03-24 | 9-140M FS+60d | 470d | 241d | 8/5 M-F w/JLAB Holidays ReBaseline | PROCUREMENT<$50K 60 | 42,735.11 | 242211885 | ELOUADRHIRI L | 1 | 1 | D | LATIFA E |  | Pat | 11-005 | MECH |  |  |  |  | 13-002F |  | 13-015 | PR | 14-001 | PE |  |  |
| 242211825 | Installation MECH GRP - AC Distribution - proc prep - Labor |  | 10d | 2014-01-09 | 2014-01-23 | 9-140M FS+62d | 434d | 0d | 8/5 M-F w/JLAB Holidays ReBaseline | MECH TECH; ELEC TECH [40 h] | 1,879.6 | 242211825 | ELOUADRHIRI L | 1 | 1 | H | LATIFA E |  | Pat | 11-005 | MECH | 11-058 |  |  | 12-054 | 13-002F | PE | 13-015 | PR | 14-001 |  |  |  |
| 242211830 | Installation MECH GRP - AC Distribution - Proc |  | 21d | 2014-01-24 | 2014-02-21 | 242211825 | 434d | 205d | 8/5 M-F w/JLAB Holidays ReBaseline | PROCUREMENT<$50K 60 | 8,076.07 | 242211830 | ELOUADRHIRI L | 1 | 1 | D | LATIFA E |  | Pat | 11-005 | MECH | 11-058 |  |  | 12-054 | 13-002F |  | 13-015 | PR | 14-001 | PE |  |  |
| 242211690 | MECH GRP - Region 4 Support, cooling, coldplate, and alignment structure: procurement prep - Labor |  | 10d | 2014-02-03 | 2014-02-14 | 242211685, 9-140M FS+10d | 269d | 0d | 8/5 M-F w/JLAB Holidays ReBaseline | MECH ENG [8 h] | 597.36 | 242211690 | ELOUADRHIRI L | 1 | 1 | H | LATIFA E |  | Pat | 11-005 | MECH | 11-058 |  |  | 12-054 | 13-002F | PE | 13-015 | PR | 14-001 |  |  |  |
| 242211800 | Installation MECH GRP - Support and alignment tube, MFG Drawings - Labor |  | 42d | 2014-02-03 | 2014-04-01 | 9-140M FS+78d | 294d | 0d | 8/5 M-F w/JLAB Holidays ReBaseline | PLABOR; MECH ENG [80 h] | 13,370.26 | 242211800 | ELOUADRHIRI L | 1 | 1 | S | LATIFA E | ST | Pat | 11-005 | MECH | 11-058 |  |  | 12-054 | 13-002F | PE | 13-015 | PR | 14-001 |  | PE |  |
| 242211745 | MECH GRP - Environmental Control System - Proc |  | 161d | 2014-02-05 | 2014-09-22 | 9-140M FS+80d | 235d | 6d | 8/5 M-F w/JLAB Holidays ReBaseline | PROCUREMENT<$50K 60 | 24,794.12 | 242211745 | ELOUADRHIRI L | 1 | 1 | D | LATIFA E |  | Pat | 11-005 | MECH | 11-058 |  |  | 12-054 | 13-002F |  | 13-015 | PR | 14-001 | CP |  |  |
| 242211415 | MECH GRP - Faraday cage protective enclosure system - Proc |  | 12d | 2014-02-14 | 2014-03-03 | 242211410, 242211410a | 299d | 44d | 8/5 M-F w/JLAB Holidays ReBaseline | PROCUREMENT<$50K 60 | 12,973.05 | 242211415 | ELOUADRHIRI L | 1 | 1 | D | LATIFA E |  | Pat | 11-005 | MECH |  | 12-027 |  | 12-054 | 13-002F |  | 13-015 | PR | 14-001 | EJ |  |  |
| 242211695 | MECH GRP - Region 4 Support, cooling, coldplate, and alignment structure: - Proc |  | 31d | 2014-02-17 | 2014-03-31 | 242211690 | 269d | 0d | 8/5 M-F w/JLAB Holidays ReBaseline | PROCUREMENT<$50K 60 | 18,378.14 | 242211695 | ELOUADRHIRI L | 1 | 1 | D | LATIFA E |  | Pat | 11-005 | MECH | 11-058 |  |  | 12-054 | 13-002F |  | 13-015 | PR | 14-001 | EJ |  |  |
| 242211730 | MECH GRP - Tooling for disassembly and repairs: procurement prep - Labor |  | 10d | 2014-03-03 | 2014-03-14 | 242211725 | 355d | 0d | 8/5 M-F w/JLAB Holidays ReBaseline | PLABOR; MECH ENG [16 h] | 1,194.72 | 242211730 | ELOUADRHIRI L | 1 | 1 | H | LATIFA E |  | Pat | 11-005 | MECH | 11-058 |  |  | 12-054 | 13-002F | PE | 13-015 | PR | 14-001 |  |  |  |
| 242211875a | MECH GRP - Construct silicon module shipping containers -Proc Part B |  | 98d | 2014-03-05 | 2014-07-22 | 9-140M FS+100d | 247d | 14d | 8/5 M-F w/JLAB Holidays ReBaseline | PROCUREMENT<$50K 60 | 30,981.77 | 242211875 | ELOUADRHIRI L | 1 | 1 | D | LATIFA E |  | Pat | 11-005 | MECH |  |  |  |  | 13-002F |  | 13-015 | PR | 14-001 | PE |  |  |
| 242211735 | MECH GRP - Tooling for disassembly, and repairs - Proc |  | 54d | 2014-03-17 | 2014-05-30 | 242211730 | 355d | 0d | 8/5 M-F w/JLAB Holidays ReBaseline | SUPPLIES & MATERIALS; PROCUREMENT<$50K 60 | 12,104.19 | 242211735 | ELOUADRHIRI L | 1 | 1 | D | LATIFA E |  | Pat | 11-005 | MECH | 11-058 |  |  | 12-054 | 13-002F |  | 13-015 | PR | 14-001 | EJ |  |  |
| 242211700 | MECH GRP - Region 4 Support, cooling, coldplate, and alignment structure: construct & assemble - Labor |  | 14d | 2014-04-01 | 2014-04-18 | 242211695 | 269d | 20d | 8/5 M-F w/JLAB Holidays ReBaseline | PLABOR; MECH ENG [40 h]; MECH TECH [160 h] | 12,407.16 | 242211700 | ELOUADRHIRI L | 1 | 1 | S | LATIFA E | ST | Pat | 11-005 | MECH | 11-058 |  |  | 12-054 | 13-002F | PE | 13-015 | PR | 14-001 |  | PE |  |
| 242211660 | INFRA STR - Backup Environmental and power system for SVT Clean Room - Proc |  | 43d | 2014-04-02 | 2014-06-02 | 9-140M FS+120d | 313d | 84d | 8/5 M-F w/JLAB Holidays ReBaseline | PROCUREMENT<$50K 60 | 6,448.34 | 242211660 | ELOUADRHIRI L | 1 | 1 | D | LATIFA E |  | Pat | 11-005 | MECH | 11-058 |  |  | 12-054 | 13-002F |  | 13-015 | PR | 14-001 | EJ |  |  |
| 242211675 | INFRA STR - Integrated Humidity Reduction System for SVT Control room - Proc |  | 43d | 2014-04-02 | 2014-06-02 | 9-140M FS+120d | 313d | 84d | 8/5 M-F w/JLAB Holidays ReBaseline | PROCUREMENT<$50K 60 | 8,776.54 | 242211670 | ELOUADRHIRI L | 1 | 1 | D | LATIFA E |  | Pat | 11-005 | MECH | 11-058 |  |  | 12-054 | 13-002F |  | 13-015 | PR | 14-001 | PE |  |  |
| 242211805 | Installation MECH GRP - Support & alignment tube - Proc - prep - Labor |  | 10d | 2014-04-02 | 2014-04-15 | 242211800 | 294d | 0d | 8/5 M-F w/JLAB Holidays ReBaseline | MECH TECH [40 h] | 1,892.8 | 242211805 | ELOUADRHIRI L | 1 | 1 | H | LATIFA E |  | Pat | 11-005 | MECH | 11-058 |  |  | 12-054 | 13-002F | PE | 13-015 | PR | 14-001 |  |  |  |
| 242211810 | Installation MECH GRP - Support and alignment tube - Proc |  | 33d | 2014-04-16 | 2014-06-02 | 242211805 | 294d | 0d | 8/5 M-F w/JLAB Holidays ReBaseline | PROCUREMENT<$50K 60 | 16,481.78 | 242211810 | ELOUADRHIRI L | 1 | 1 | D | LATIFA E |  | Pat | 11-005 | MECH | 11-058 |  |  | 12-054 | 13-002F |  | 13-015 | PR | 14-001 | EJ |  |  |
| 242211740 | MECH GRP - Tooling for disassembly and repairs Build - Labor |  | 30d | 2014-05-02 | 2014-06-13 | 242211735 FS-20d | 355d | 126d | 8/5 M-F w/JLAB Holidays ReBaseline | PLABOR; MECH ENG [40 h]; MECH TECH [160 h] | 14,256.33 | 242211740 | ELOUADRHIRI L | 1 | 1 | S | LATIFA E | ST | Pat | 11-005 | MECH | 11-058 |  |  | 12-054 | 13-002F | PE | 13-015 | PR | 14-001 |  | PE |  |
| 242211860 | Installation MECH GRP - Purging system: procurement prep - Labor |  | 10d | 2014-05-14 | 2014-05-28 | 9-140M FS+150d | 275d | 0d | 8/5 M-F w/JLAB Holidays ReBaseline | MECH ENG [40 h] | 2,986.8 | 242211860 | ELOUADRHIRI L | 1 | 1 | H | LATIFA E |  | Pat | 11-005 | MECH |  |  |  |  | 13-002F | PE | 13-015 | PR | 14-001 |  |  |  |
| 242211545 | MECH GRP - Mounting and aligning on support structure in lab, R4 - Labor |  | 54d | 2014-05-19 | 2014-08-04 | 242211700, 242211615 FS-10d | 249d | 0d | 8/5 M-F w/JLAB Holidays ReBaseline | PLABOR; MECH TECH [240 h]; MECH ENG [40 h] | 16,192.76 | 242211545 | ELOUADRHIRI L | 1 | 1 | S | LATIFA E | ST | Pat | 11-005 | MECH | 11-058 |  |  | 12-054 | 13-002F | PE | 13-015 | PR | 14-001 |  | PE |  |
| 242211865 | Installation MECH GRP - Purging system: installation - Proc |  | 21d | 2014-05-29 | 2014-06-26 | 242211860 | 275d | 26d | 8/5 M-F w/JLAB Holidays ReBaseline | PROCUREMENT<$50K 60 | 5,493.93 | 242211865 | ELOUADRHIRI L | 1 | 1 | D | LATIFA E |  | Pat | 11-005 | MECH |  |  |  |  | 13-002F |  | 13-015 | PR | 14-001 | EJ |  |  |
| 242211815 | Installation MECH GRP - Support and alignment (construction) - Labor |  | 19d | 2014-06-03 | 2014-06-27 | 242211810 | 294d | 65d | 8/5 M-F w/JLAB Holidays ReBaseline | MECH ENG [40 h]; MECH TECH [80 h] | 6,772.4 | 242211815 | ELOUADRHIRI L | 1 | 1 | H | LATIFA E |  | Pat | 11-005 | MECH | 11-058 |  |  | 12-054 | 13-002F | PE | 13-015 | PR | 14-001 |  |  |  |
| 242211600 | HBI - Full system R4, test and burn-in in Cleanroom EEL 121 - Labor |  | 20d | 2014-07-22 | 2014-08-18 | 242211367, 242211545 FS-10d | 259d | 30d | 8/5 M-F w/JLAB Holidays ReBaseline | ELEC ENG [160 h]; ELEC TECH [160 h]; VISTNG USERS [320 h] | 26,128 | 242211600 | ELOUADRHIRI L | 1 | 1 | S | LATIFA E | ST | Pat | 11-005 | MECH | 11-058 |  |  | 12-054 | 13-002F | PE | 13-015 | PR | 14-001 |  |  |  |
| 242211870 | Installation MECH GRP - Purging system: installation in clean room- Labor |  | 20d | 2014-08-05 | 2014-09-02 | 242211865, 242211545 | 249d | 20d | 8/5 M-F w/JLAB Holidays ReBaseline | PLABOR; MECH ENG [40 h]; MECH TECH [80 h] | 6,772.4 | 242211870 | ELOUADRHIRI L | 1 | 1 | H | LATIFA E |  | Pat | 11-005 | MECH |  |  |  |  | 13-002F | PE | 13-015 | PR | 14-001 |  |  |  |
| 242211495M | End of BST R1-R4 Production | milestone | 0d | 2014-09-30 | 2014-09-30 | 242211876 FS-15d, 242211490, 242211490a | 229d | 0d | 8/5 M-F w/JLAB Holidays ReBaseline |  |  | 242211495M | ELOUADRHIRI L | 1 | 1 | M | LATIFA E |  | Pat | 11-005 | MECH | 11-058 |  |  | 12-054 | 13-002F |  | 13-015 | PR |  |  |  |  |
| 242211145 | HBI - SVT Engineering and Construction Oversight FY15 |  | 23d | 2014-10-01 | 2014-10-31 | 242211014E, 242211140 | 719d | 528d | 8/5 M-F w/JLAB Holidays ReBaseline | SCIENTIST [160 h] | 12,028.8 | 242211145 | ELOUADRHIRI L | 1 | 1 | E | LATIFA E |  | Pat | 11-005 | HBI |  |  |  |  |  | PE | 13-015 | PR | 14-001 |  |  | 12-001 |
| 242211680 | MECH GRP - Full system test Integration of SVT R3/R4 - Labor |  | 51d | 2014-10-01 | 2014-12-12 | 242211745, 242211395, 242211815, 242211660, 242211635, 242211400a, 242211655, 242211600, 242211495M, 242211870, 242211675, 242211670 | 229d | 0d | 8/5 M-F w/JLAB Holidays ReBaseline | ELEC ENG [148 h]; ELEC TECH [148 h]; MECH ENG [72 h]; MECH TECH [220 h]; VISTNG USERS [240 h] | 38,802 | 242211680 | ELOUADRHIRI L | 1 | 1 | S | LATIFA E | ST | Pat | 11-005 | MECH | 11-058 |  |  | 12-054 | 13-002F | PE | 13-015 | PR | 14-001 |  |  |  |
| 242211918M | SVT Ready for Installation | milestone | 0d | 2014-12-12 | 2014-12-12 | 242211530, 242211680, 242211740, 242211145 FS-500d, 242211755, 242211830, 242211361 | 229d | 0d | 8/5 M-F w/JLAB Holidays ReBaseline |  |  | 242211918M | ELOUADRHIRI L | 1 | 1 | M | LATIFA E |  | Pat | 11-005 |  | 11-058 |  |  | 12-054 | 13-002F |  | 13-015 | PR |  |  |  |  |

Notes:
- 242211400a: Steps: Write LabVIEW based slow controls monitoring program; Develop user apps and GUI; Test and debug monitoring program
- 242211800: Steps: Completion of CAD model; Completion of drawings; Drawings review and release
- 242211700: Steps: Inspection of parts; Assembly of parts
- 242211740: Steps: Check parts; Assemble fixture
- 242211545: Steps: Assembly set-up; Assemble Region 4; Assemble outer shell and Faraday cage
- 242211600: Steps: Checkout of Front-End electronics; Checkout of the High-Voltage system and distribution; Checkout of the Low-Voltage System; Checkout of DAQ and Trigger; Checkout of gas system; Checkout of safety system (interlock LV/HV/cooling/gas
- 242211680: Steps: Transport R3 and R4 to the large clean room.; Insert and attach R3 to R4; Hook all services (cooling lines, nitrogen gas lines, power supplies, and interlocks); Survey position of R3 with respect to R4; Install Faraday cage over R4
- 242211918M: Steps: (New step)

| ID | WBS | Activity | Type | Duration | Start | Finish | Predecessors | Total float | Free float | Resources | Cost | RESP - Responsibility | STRT%COMP for CM EVM | FNSH%COMP for CM EVM | Milestone Level | CAM RESPONSIBLE | CR 10-015 | CR 11-026 | CR 11-027 | CR 11-035 | CR 13-002 | CR 07-024 | CR 08-058 | Advance Purchase Plan > 500K | CR 09-026 | CR 10-001 | CR 08-046 | CR 08-016 | CR 09-012 | CR 11-038 | CR 08-043 | CR 10-026 | CR 11-001 | CR 11-010 | CR 11-031 | CR 12-001 | CR 12-053 |
| --- | --- | --- | --- | --- | --- | --- | --- | --- | --- | --- | --- | --- | --- | --- | --- | --- | --- | --- | --- | --- | --- | --- | --- | --- | --- | --- | --- | --- | --- | --- | --- | --- | --- | --- | --- | --- | --- |
|  | 2 | **1.4.2.2.1.2 CENTRAL TRACKER** |  |  |  |  |  |  |  |  |  |  |  |  |  |  |  |  |  |  |  |  |  |  |  |  |  |  |  |  |  |  |  |  |  |  |  |
|  | 3 | **1.4.2.2.1.3 FORWARD DRIFT CHAMBERS** |  |  | 2008-10-01 | 2015-04-01 |  |  |  |  |  |  |  |  |  |  |  |  |  |  |  |  |  |  |  |  |  |  |  |  |  |  |  |  |  |  |  |
| 142213000M |  | DC-P-#1 Constrction Start P-#1 (F DRFT CHAM) | milestone | 0d | 2008-10-01 | 2008-10-01 | 9-090M, 12222035M | 392d | 145d |  |  | ELOUADRHIRI L | 1 | 1 | 6 | LATIFA E | 10-015 | 11-026 | 11-027 | 11 -035 | 13-002F |  |  |  |  |  |  |  |  |  |  |  |  |  |  |  |  |
| 142213009E |  | FY09 Travel (FWD Chambers) |  | 189d | 2009-01-02 | 2009-09-30 | 142213009EX | 248d | 0d | TRAVEL | 2,028.73 | ELOUADRHIRI L | 1 | 1 |  | LATIFA E | 10-015 | 11-026 |  | 11 -035 | 13-002F | 07-024 | 08-058 |  |  |  |  |  |  |  |  |  |  |  |  |  |  |
| 142213017 |  | P-#1 Proc Endplates & Frames LABOR Initial |  | 82d | 2009-01-05 | 2009-04-30 | 9-090M FS+60d | 60d | 0d | SCIENTIST [60.55 h]; CONTRB UNIV LBR [121.11 h]; PD UNIV STAFF [565.17 h]; MECH DES [141.3 h]; MECH ENG [80.74 h]; MECH TECH [222.03 h] | 53,121.45 | ELOUADRHIRI L | 1 | 1 |  | LATIFA E | 10-015 | 11-026 |  | 11 -035 | 13-002F |  |  | APP | 09-026 |  |  |  |  |  |  |  |  |  |  |  |  |
| 142213017A |  | P-#1 Proc Endplates & Frames LABOR Final FY09 |  | 106d | 2009-05-01 | 2009-09-30 | 142213017 | 60d | 0d | MECH TECH [199.89 h]; CONTRB UNIV LBR [59.64 h] | 8,085.55 | ELOUADRHIRI L | 1 | 1 |  | LATIFA E | 10-015 | 11-026 |  | 11 -035 | 13-002F |  |  | APP | 09-026 | 10-001B |  |  |  |  |  |  |  |  |  |  |  |
| 142213020 |  | P-#1 Proc Box Assy. Fixtures LABOR |  | 60d | 2009-05-06 | 2009-07-30 | 9-090M FS+145d | 196d | 57d | MECH TECH [160 h] | 6,472 | ELOUADRHIRI L | 1 | 1 |  | LATIFA E | 10-015 | 11-026 | 11-027 | 11 -035 | 13-002F |  |  | APP | 09-026 |  |  |  |  |  |  |  |  |  |  |  |  |
| 142213022 |  | P-#1 Proc Wires, Pins and Feedthroughs LABOR |  | 103d | 2009-05-06 | 2009-09-30 | 142213000M, 9-090M FS+145d | 247d | 108d | MECH TECH [472 h]; CONTRB UNIV LBR [160 h] | 19,092.4 | ELOUADRHIRI L | 1 | 1 |  | LATIFA E | 10-015 | 11-026 | 11-027 | 11 -035 | 13-002F |  |  | APP | 09-026 |  | 08-046 |  |  |  |  |  |  |  |  |  |  |
| 142213022P |  | P-#1 Proc Wires, Pins and Feedthroughs |  | 206d | 2009-05-06 | 2010-03-08 | 9-090M FS+145d | 144d | 5d | PROCUREMENT<$50K 60 NO ESCALATION FY10; PROCUREMENT>$50K 69 NO ESCALATION FY10 | 601,100 | ELOUADRHIRI L | 1 | 1 |  | LATIFA E | 10-015 | 11-026 | 11-027 | 11 -035 | 13-002F |  |  | APP | 09-026 |  | 08-046 |  |  |  |  |  |  |  |  |  |  |
| 142213030 |  | P-#1 Proc Circuit Boards LABOR |  | 88d | 2009-05-06 | 2009-09-09 | 9-090M FS+145d | 262d | 123d | ELEC DES [704 h]; ELEC ENG [40 h]; ELEC TECH [40 h] | 36,545.92 | ELOUADRHIRI L | 1 | 1 |  | LATIFA E | 10-015 | 11-026 | 11-027 | 11 -035 | 13-002F |  |  | APP | 09-026 |  |  |  |  |  |  |  |  |  |  |  |  |
| 142213035 |  | P-#1 Build Stringing Fixtures, Machines and Platforms |  | 103d | 2009-05-06 | 2009-09-30 | 9-090M FS+145d | 247d | 108d | MECH ENG [206 h]; PLABOR; SKLLD TRADE [64 h]; CONTRB UNIV LBR [360 h]; MECH TECH [218.4 h] | 38,927.94 | ELOUADRHIRI L | 1 | 1 |  | LATIFA E | 10-015 | 11-026 | 11-027 | 11 -035 | 13-002F |  |  | APP | 09-026 |  |  | 08-016 | 09-012 |  |  |  |  |  |  |  |  |
| 142213017P |  | P-#1 Proc Frames/Endplates |  | 112d | 2009-05-13 | 2009-10-20 | 9-090M FS+150d | 139d | 0d | PROCUREMENT<$50K 60 NO ESCALATION FY10 | 93,800 | ELOUADRHIRI L | 1 | 1 |  | LATIFA E | 10-015 | 11-026 | 11-027 | 11 -035 | 13-002F |  |  | APP | 09-026 |  |  |  |  |  |  |  |  |  |  |  |  |
| 142213020P |  | P-#1 Proc Box Assy. Fixtures |  | 60d | 2009-05-20 | 2009-08-13 | 9-090M FS+155d | 186d | 47d | PROCUREMENT<$50K 60 | 57,800 | ELOUADRHIRI L | 1 | 1 |  | LATIFA E | 10-015 | 11-026 | 11-027 | 11 -035 | 13-002F |  |  | APP | 09-026 |  |  |  |  |  |  |  |  |  |  |  |  |
| 142213035P |  | P-#1 Proc Cleanroom Fixtures and Equipment |  | 30d | 2009-06-11 | 2009-07-23 | 9-090M FS+170d | 295d | 156d | PROCUREMENT<$50K 60 | 70,400 | ELOUADRHIRI L | 1 | 1 |  | LATIFA E | 10-015 | 11-026 | 11-027 | 11 -035 | 13-002F |  |  | APP | 09-026 |  |  | 08-016 | 09-012 |  |  |  |  |  |  |  |  |
| 142213030P |  | P-#1 Proc Circuit Boards |  | 90d | 2009-07-31 | 2009-12-08 | 9-090M FS+205d | 200d | 61d | PROCUREMENT<$50K 60 NO ESCALATION FY10 | 17,200 | ELOUADRHIRI L | 1 | 1 |  | LATIFA E | 10-015 | 11-026 | 11-027 | 11 -035 | 13-002F |  |  | APP | 09-026 |  |  |  |  |  |  |  |  |  |  |  |  |
| 142213010E |  | FY10 Travel (FWD Chambers) |  | 248d | 2009-10-01 | 2010-09-30 | 142213009E | 248d | 0d | TRAVEL | 2,746.96 | ELOUADRHIRI L | 1 | 1 |  | LATIFA E | 10-015 | 11-026 |  | 11 -035 | 13-002F | 07-024 |  |  |  |  |  |  |  |  |  |  |  |  |  |  |  |
| 142213017Ab |  | P-#1 Proc Endplates & Frames LABOR Final FY10 |  | 20d | 2009-10-01 | 2009-10-28 | 142213017A | 60d | 0d | MECH TECH [37.71 h]; CONTRB UNIV LBR [11.25 h] | 1,574.02 | ELOUADRHIRI L | 1 | 1 |  | LATIFA E | 10-015 | 11-026 |  | 11 -035 | 13-002F |  |  | APP |  | 10-001B |  |  |  |  |  |  |  |  |  |  |  |
| 142213100M |  | P-#2 Constrction Start P-#2 | milestone | 0d | 2009-10-01 | 2009-10-01 | 9-100M | 184d | 0d |  |  | ELOUADRHIRI L | 1 | 1 | 6 | LATIFA E | 10-015 | 11-026 | 11-027 | 11 -035 | 13-002F |  |  |  | 09-026 |  |  |  |  | 11-038 |  |  |  |  |  |  |  |
| 142213122 |  | P-#2 Proc Wires, Pins and Feedthroughs LABOR |  | 120d | 2009-10-01 | 2010-03-31 | 142213100M | 312d | 173d | MECH TECH [8 h]; CONTRB UNIV LBR [80 h] | 333.92 | ELOUADRHIRI L | 1 | 1 |  | LATIFA E | 10-015 | 11-026 | 11-027 | 11 -035 | 13-002F |  |  | APP | 09-026 |  |  |  |  |  | 08-043 |  |  |  |  |  |  |
| 142213135 |  | P-#2 Build Stringing Fixtures, Machines and Platforms |  | 162d | 2009-10-01 | 2010-05-28 | 142213100M | 270d | 131d | SKLLD TRADE [128.8 h]; MECH ENG [324 h]; PLABOR; MECH TECH [272.4 h] | 74,756.1 | ELOUADRHIRI L | 1 | 1 |  | LATIFA E | 10-015 | 11-026 | 11-027 | 11 -035 | 13-002F |  |  |  | 09-026 |  |  |  |  |  | 08-043 |  |  |  |  |  |  |
| 142213122P |  | P-#2 Proc Wires, Pins and Feedthroughs |  | 70d | 2009-10-15 | 2010-02-02 | 142213100M FS+10d | 352d | 213d | PROCUREMENT<$50K 60 | 10,319 | ELOUADRHIRI L | 1 | 1 |  | LATIFA E | 10-015 | 11-026 | 11-027 | 11 -035 | 13-002F |  |  | APP | 09-026 |  |  |  |  |  | 08-043 |  |  |  |  |  |  |
| 142213032 |  | P-#1 Build Boxes and Associated Hardware |  | 94d | 2009-10-21 | 2010-03-15 | 142213020, 142213017P, 142213020P, 9-100M, 142213017Ab FS-20d | 139d | 0d | PD UNIV STAFF [80 h]; SKLLD TRADE [120 h]; PLABOR; MECH ENG [188 h]; MECH TECH [284.4 h] | 58,040.16 | ELOUADRHIRI L | 1 | 1 |  | LATIFA E | 10-015 | 11-026 | 11-027 | 11 -035 | 13-002F |  |  |  | 09-026 |  |  |  |  |  |  |  |  |  |  |  |  |
| 142213117 |  | P-#2 Proc Endplates & Frames LABOR Initial |  | 161d | 2009-10-29 | 2010-06-25 | 142213017Ab | 60d | 0d | CONTRB UNIV LBR [40 h]; MECH TECH [560 h] | 23,374.4 | ELOUADRHIRI L | 1 | 1 |  | LATIFA E | 10-015 | 11-026 |  | 11 -035 | 13-002F |  |  | APP | 09-026 |  |  |  |  |  |  |  |  |  |  |  |  |
| 142213042M |  | First Wire Strung | milestone | 0d | 2009-11-02 | 2009-11-02 | 142213042 FS-140d | 969d |  |  |  | ELOUADRHIRI L | 1 | 1 |  | LATIFA E | 10-015 | 11-026 |  | 11 -035 | 13-002F |  |  |  | 09-026 |  |  |  |  |  |  |  |  |  |  |  |  |
| 142213117P |  | P-#2 Proc Frames/Endplates |  | 110d | 2009-11-06 | 2010-04-22 | 142213100M FS+26d | 255d | 0d | PROCUREMENT>$50K 69; PROCUREMENT<$50K 60 | 225,986.1 | ELOUADRHIRI L | 1 | 1 |  | LATIFA E | 10-015 | 11-026 | 11-027 | 11 -035 | 13-002F |  |  | APP | 09-026 |  |  |  |  | 11-038 |  |  |  |  |  |  |  |
| 142213120 |  | P-#2 Proc Box Assy. Fixtures LABOR |  | 60d | 2009-12-08 | 2010-03-11 | 142213100M FS+46d | 285d | 142d | MECH TECH [360 h] | 15,026.4 | ELOUADRHIRI L | 1 | 1 |  | LATIFA E | 10-015 | 11-026 | 11-027 | 11 -035 | 13-002F |  |  | APP | 09-026 |  |  |  |  | 11-038 |  |  |  |  |  |  |  |
| 142213135P |  | P-#2 Proc Cleanroom Fixtures and Equipment |  | 60d | 2009-12-08 | 2010-03-11 | 142213100M FS+46d | 326d | 187d | PROCUREMENT<$50K 60; PROCUREMENT>$50K 69 | 145,704.28 | ELOUADRHIRI L | 1 | 1 |  | LATIFA E | 10-015 | 11-026 | 11-027 | 11 -035 | 13-002F |  |  |  | 09-026 |  |  |  |  |  | 08-043 |  |  |  |  |  |  |
| 142213120P |  | P-#2 Proc Box Assy. Fixtures |  | 34d | 2010-01-14 | 2010-03-04 | 142213100M FS+67d | 290d | 147d | PROCUREMENT<$50K 60 | 87,298.74 | ELOUADRHIRI L | 1 | 1 |  | LATIFA E | 10-015 | 11-026 | 11-027 | 11 -035 | 13-002F |  |  | APP | 09-026 |  |  |  |  | 11-038 |  |  |  |  |  |  |  |
| 142213130 |  | P-#2 Proc Circuit Boards LABOR |  | 148d | 2010-03-04 | 2010-09-30 | 142213100M FS+100d | 184d | 45d | ELEC TECH [40 h] | 1,658 | ELOUADRHIRI L | 1 | 1 |  | LATIFA E | 10-015 | 11-026 | 11-027 | 11 -035 | 13-002F |  |  | APP | 09-026 |  |  |  |  |  | 08-043 |  |  |  |  |  |  |
| 142213042 |  | P-#1 String Chambers Initial |  | 54d | 2010-03-16 | 2010-05-28 | 142213032, 142213035, 9-100M FS+108d, 142213030, 142213035P, 142213022, 142213022P, 142213030P | 139d | 0d | PLABOR; PD UNIV STAFF [493.79 h]; SCIENTIST [9.26 h]; CONTRB UNIV LBR [123.45 h]; MECH TECH [437.02 h]; MECH ENG [108.02 h] | 101,207.56 | ELOUADRHIRI L | 1 | 1 |  | LATIFA E | 10-015 | 11-026 | 11-027 | 11 -035 | 13-002F |  |  |  | 09-026 |  |  |  |  |  |  |  |  |  |  |  |  |
| 142213130P |  | P-#2 Proc Circuit Boards Initial |  | 69d | 2010-03-25 | 2010-06-30 | 142213100M FS+115d | 184d | 0d | PROCUREMENT<$50K 60 | 54,310.96 | ELOUADRHIRI L | 1 | 1 |  | LATIFA E | 10-015 | 11-026 | 11-027 | 11 -035 | 13-002F |  |  | APP | 09-026 |  |  |  |  |  | 08-043 |  |  |  |  |  |  |
| 142213217P |  | P-#3 Proc Frames/Endplates |  | 196d | 2010-05-11 | 2011-02-28 | 142213117P FS+12.5d | 460.5d | 151.5d | PROCUREMENT<$50K 60 NO ESCALATION FY11 | 105,614 | ELOUADRHIRI L | 1 | 1 |  | LATIFA E | 10-015 | 11-026 | 11-027 | 11 -035 | 13-002F |  |  | APP | 09-026 |  |  |  |  |  |  | 10-026 |  |  |  |  |  |
| 142213042B |  | P-#1 String Chambers Final FY10 |  | 86d | 2010-06-01 | 2010-09-30 | 142213042 | 139d | 0d | PD UNIV STAFF [516.13 h]; SCIENTIST [9.68 h]; CONTRB UNIV LBR [129.03 h]; MECH TECH [456.31 h]; MECH ENG [112.9 h]; PLABOR | 62,729.72 | ELOUADRHIRI L | 1 | 1 |  | LATIFA E | 10-015 | 11-026 | 11-027 | 11 -035 | 13-002F |  |  |  | 09-026 |  |  |  |  |  |  |  | 11-001 |  |  |  |  |
| 142213045 |  | ODU Contract Preperations |  | 69d | 2010-06-01 | 2010-09-07 | 9-100M FS+162d | 106d | 0d | MECH TECH [49.6 h]; CONTRB UNIV LBR [200 h] | 2,070.3 | ELOUADRHIRI L | 1 | 1 |  | LATIFA E | 10-015 | 11-026 |  | 11 -035 | 13-002F |  |  |  | 09-026 |  |  |  |  |  |  |  |  | 11-010 |  |  |  |
| 142213070 |  | ISU Contract Preperations FY10 |  | 86d | 2010-06-01 | 2010-09-30 | 9-100M FS+162d | 42d | 0d | MECH TECH [48.47 h]; CONTRB UNIV LBR [195.45 h] | 2,023.14 | ELOUADRHIRI L | 1 | 1 |  | LATIFA E | 10-015 | 11-026 |  | 11 -035 | 13-002F |  |  |  | 09-026 |  |  |  |  |  |  |  | 11-001 |  | 11-031 |  |  |
| 142213117B |  | P-#2 Proc Endplates & Frames LABOR Final FY10 |  | 67d | 2010-06-28 | 2010-09-30 | 142213117, 142213017Ab | 60d | 0d | MECH DES [82.3 h]; MECH ENG [25.72 h]; MECH TECH [5.14 h] | 5,631.45 | ELOUADRHIRI L | 1 | 1 |  | LATIFA E | 10-015 | 11-026 |  | 11 -035 | 13-002F |  |  | APP | 09-026 |  |  |  |  |  |  |  | 11-001 |  |  |  |  |
| 142213130Pb |  | P-#2 Proc Circuit Boards Final |  | 64d | 2010-07-01 | 2010-09-30 | 142213130P | 184d | 45d | PROCUREMENT<$50K 60; PROCUREMENT>$50K 69 | 80,000 | ELOUADRHIRI L | 1 | 1 |  | LATIFA E | 10-015 | 11-026 | 11-027 | 11 -035 | 13-002F |  |  | APP | 09-026 |  |  |  |  |  | 08-043 |  |  |  |  |  |  |
| 142213011E |  | FY11 Travel (FWD Chambers) |  | 248d | 2010-10-01 | 2011-09-30 | 142213010E | 248d | 0d | TRAVEL | 18,174.34 | ELOUADRHIRI L | 1 | 1 |  | LATIFA E | 10-015 | 11-026 |  | 11 -035 | 13-002F | 07-024 |  |  |  |  |  |  |  |  |  |  |  |  |  |  |  |
| 142213042Ba |  | P-#1 String Chambers Final FY11 |  | 45d | 2010-10-01 | 2010-12-06 | 142213042B | 139d | 0d | SCIENTIST [5.06 h]; CONTRB UNIV LBR [67.52 h]; MECH ENG [59.08 h]; PLABOR; PD UNIV STAFF [270.07 h]; MECH TECH [238.77 h] | 33,869.67 | ELOUADRHIRI L | 1 | 1 |  | LATIFA E | 10-015 | 11-026 | 11-027 | 11 -035 | 13-002F |  |  |  | 09-026 |  |  |  |  |  |  |  | 11-001 |  |  |  |  |
| 142213070a |  | ISU Contract Preperations FY11 |  | 2d | 2010-10-01 | 2010-10-04 | 142213070 | 42d | 0d | CONTRB UNIV LBR [4.55 h]; MECH TECH [1.13 h] | 48.67 | ELOUADRHIRI L | 1 | 1 |  | LATIFA E | 10-015 | 11-026 |  | 11 -035 | 13-002F |  |  |  | 09-026 |  |  |  |  |  |  |  | 11-001 |  | 11-031 |  |  |
| 142213117Ba |  | P-#2 Proc Endplates & Frames LABOR Final FY11 |  | 248d | 2010-10-01 | 2011-09-30 | 142213117B | 60d | 0d | MECH DES [304.65 h]; MECH ENG [95.2 h]; MECH TECH [19.04 h] | 21,509.95 | ELOUADRHIRI L | 1 | 1 |  | LATIFA E | 10-015 | 11-026 |  | 11 -035 | 13-002F |  |  | APP | 09-026 |  |  |  |  |  |  |  | 11-001 |  |  | 12-001 |  |
| 142213132 |  | P-#2 Build Boxes and Associated Hardware Part A |  | 97d | 2010-10-01 | 2011-02-28 | 142213120, 142213117 FS-70d, 142213100M, 142213120P, 9-110M, 142213117P | 143d | 0d | CONTRB UNIV LBR [64.13 h]; MECH TECH [1795.64 h]; PLABOR; SKLLD TRADE [145.36 h]; MECH ENG [149.64 h] | 132,052.58 | ELOUADRHIRI L | 1 | 1 |  | LATIFA E | 10-015 | 11-026 | 11-027 | 11 -035 | 13-002F |  |  |  | 09-026 |  |  |  |  | 11-038 | 08-043 |  |  |  |  |  |  |
| 142213200M |  | P-#3 Constrction Start P-#3 | milestone | 0d | 2010-10-01 | 2010-10-01 | 9-110M | 127d | 0d |  |  | ELOUADRHIRI L | 1 | 1 | 6 | LATIFA E | 10-015 | 11-026 | 11-027 | 11 -035 | 13-002F |  |  |  | 09-026 |  |  |  |  |  | 08-043 |  |  |  |  |  |  |
| 142213220 |  | P-#3 Proc Box Assy. Fixtures LABOR |  | 35d | 2010-10-01 | 2010-11-18 | 9-110M | 708d |  | MECH TECH [64 h]; SKLLD TRADE [8 h]; MECH ENG [8 h] | 3,559.44 | ELOUADRHIRI L | 1 | 1 |  | LATIFA E | 10-015 | 11-026 |  | 11 -035 | 13-002F |  |  | APP | 09-026 |  |  |  |  |  |  |  |  |  |  |  |  |
| 142213222 |  | P-#3 Proc Wires, Pins and Feedthroughs LABOR |  | 130d | 2010-10-01 | 2011-04-14 | 9-110M | 398d | 271d | MECH TECH [120 h]; SCIENTIST [12 h]; CONTRB UNIV LBR [24 h] | 5,989.56 | ELOUADRHIRI L | 1 | 1 |  | LATIFA E | 10-015 | 11-026 | 11-027 | 11 -035 | 13-002F |  |  | APP | 09-026 |  |  |  |  |  |  |  |  |  |  |  |  |
| 142213222P |  | P-#3 Proc Wires, Pins and Feedthroughs |  | 90d | 2010-10-01 | 2011-02-16 | 9-110M | 438d | 311d | PROCUREMENT<$50K 60 | 10,319 | ELOUADRHIRI L | 1 | 1 |  | LATIFA E | 10-015 | 11-026 | 11-027 | 11 -035 | 13-002F |  |  | APP | 09-026 |  |  |  |  |  |  |  |  |  |  |  |  |
| 142213230 |  | P-#3 Proc Circuit Boards LABOR |  | 90d | 2010-10-01 | 2011-02-16 | 9-110M, 142213200M | 438d | 311d | MECH TECH [40 h]; CONTRB UNIV LBR [144 h] | 1,722.8 | ELOUADRHIRI L | 1 | 1 |  | LATIFA E | 10-015 | 11-026 | 11-027 | 11 -035 | 13-002F |  |  | APP | 09-026 |  |  |  |  |  | 08-043 |  |  |  |  |  |  |
| 142213230P |  | P-#3 Proc Circuit Boards |  | 431d | 2010-10-01 | 2012-06-29 | 9-110M, 142213200M | 127d | 0d | PROCUREMENT>$50K 69 NO ESCALATION FY12; PROCUREMENT<$50K 60 NO ESCALATION FY12 | 82,552 | ELOUADRHIRI L | 1 | 1 |  | LATIFA E | 10-015 | 11-026 | 11-027 | 11 -035 | 13-002F |  |  | APP | 09-026 |  |  |  |  |  | 08-043 |  |  |  |  |  |  |
| 142213075 |  | ISU Contract Phase 1a - Hire lead stringer, complete cleanroom, Readiness Review |  | 95d | 2010-10-05 | 2011-02-28 | 142213070a | 42d | 0d | PROCUREMENT<$50K 60; PROCUREMENT>$50K 69 | 127,253.91 | ELOUADRHIRI L | 1 | 1 |  | LATIFA E | 10-015 | 11-026 |  | 11 -035 | 13-002F |  |  |  | 09-026 |  |  |  |  |  |  |  |  |  | 11-031 |  |  |
| 142213220P |  | P-#3 Proc Box Assy. Fixtures |  | 30d | 2010-11-03 | 2010-12-16 | 9-110M FS+23d | 504d | 195d | PROCUREMENT<$50K 60 | 29,925.1 | ELOUADRHIRI L | 1 | 1 |  | LATIFA E | 10-015 | 11-026 | 11-027 | 11 -035 | 13-002F |  |  | APP | 09-026 |  |  |  |  |  |  |  |  |  |  |  |  |
| 142213050 |  | ODU Contract Peg Point #1 Boxes Built & Ready to String |  | 207d | 2010-12-01 | 2011-09-30 | 142213045 FS+58d | 106d | 0d | PROCUREMENT<$50K 60 NO ESCALATION; PROCUREMENT>$50K 69 NO ESCALATION | 105,000 | ELOUADRHIRI L | 1 | 1 |  | LATIFA E | 10-015 | 11-026 |  | 11 -035 | 13-002F |  |  |  | 09-026 |  |  |  |  |  |  |  |  | 11-010 |  |  |  |
| 142213055 |  | ODU Contract Peg Point #2 Hire and Train First two Stringers |  | 121d | 2010-12-01 | 2011-05-31 | 142213050 FS-207d | 106d | 0d | PROCUREMENT>$50K 69 NO ESCALATION | 118,000 | ELOUADRHIRI L | 1 | 1 |  | LATIFA E | 10-015 | 11-026 |  | 11 -035 | 13-002F |  |  |  | 09-026 |  |  |  |  |  |  |  |  | 11-010 |  |  |  |
| 142213142 |  | P-#2 String Chambers Part A |  | 52d | 2010-12-07 | 2011-02-28 | 142213122, 142213130Pb, 142213130, 142213135P, 142213135, 142213042Ba, 142213100M, 142213122P, 142213130P | 139d | 0d | MECH TECH [349.52 h]; PLABOR | 59,120.99 | ELOUADRHIRI L | 1 | 1 |  | LATIFA E | 10-015 | 11-026 | 11-027 | 11 -035 | 13-002F |  |  |  | 09-026 |  |  |  | 09-012 |  | 08-043 |  |  |  |  |  |  |
| 142213060 |  | ODU Contract Peg Point #3 Hire and Train Second two Stringers |  | 191d | 2011-02-01 | 2011-10-31 | 142213055 FS-84d | 106d | 0d | PROCUREMENT>$50K 69 NO ESCALATION; PROCUREMENT<$50K 60 NO ESCALATION | 81,914.64 | ELOUADRHIRI L | 1 | 1 |  | LATIFA E | 10-015 | 11-026 |  | 11 -035 | 13-002F |  |  |  | 09-026 |  |  |  |  |  |  |  |  | 11-010 |  |  |  |
| 142213133 |  | P-#2 Build Boxes and Associated Hardware Part B (Frozen by Administrative CR 11-38) |  | 44d | 2011-03-01 | 2011-04-29 | 142213132 | 661d | 641d | MECH ENG [38.24 h]; CONTRB UNIV LBR [16.39 h]; MECH TECH [458.88 h]; PLABOR; SKLLD TRADE [9.2 h] | 25,180.36 | ELOUADRHIRI L | 1 | 1 |  | LATIFA E | 10-015 | 11-026 | 11-027 | 11 -035 | 13-002F |  |  |  | 09-026 |  |  |  |  | 11-038 | 08-043 |  |  |  |  |  |  |
| 142213144 |  | P-#2 String Chambers Part B FY11 |  | 151d | 2011-03-01 | 2011-09-30 | 142213142 | 139d | 0d | PLABOR; MECH TECH [524.86 h] | 102,741.2 | ELOUADRHIRI L | 1 | 1 |  | LATIFA E | 10-015 | 11-026 | 11-027 | 11 -035 | 13-002F |  |  |  | 09-026 |  |  |  | 09-012 |  | 08-043 |  |  |  |  | 12-001 |  |
| 142213235 |  | P-#3 Build Stringing Fixtures, Machines and Platforms FY11 |  | 148d | 2011-03-04 | 2011-09-30 | 9-110M FS+100d, 142213135 | 429d | 0d | MECH DES [300.81 h]; MECH TECH [150.41 h]; MECH ENG [138.37 h] | 29,922.21 | ELOUADRHIRI L | 1 | 1 |  | LATIFA E | 10-015 | 11-026 | 11-027 | 11 -035 | 13-002F |  |  |  | 09-026 |  |  |  |  |  | 08-043 |  |  |  |  | 12-001 |  |
| 142213080 |  | ISU Contract Phase 1b - Hire and train first 2 stringers, install and tension chamber 2 |  | 143d | 2011-04-11 | 2011-10-31 | 142213075 FS+29d | 42d | 0d | PROCUREMENT>$50K 69 NO ESCALATION | 37,746.09 | ELOUADRHIRI L | 1 | 1 |  | LATIFA E | 10-015 | 11-026 | 11-027 | 11 -035 | 13-002F |  |  |  | 09-026 |  |  |  |  |  |  |  |  |  | 11-031 |  |  |
| 142213133a |  | Reverse Entry per Administrative CR 11-38 |  | 5d | 2011-05-02 | 2011-05-06 | 9-110M FS+141d | 102d |  | MECH ENG [-38.24 h]; CONTRB UNIV LBR [-16.39 h]; MECH TECH [-458.88 h]; PLABOR; SKLLD TRADE [-9.2 h] | -25,180.36 | ELOUADRHIRI L | 1 | 1 |  | LATIFA E | 10-015 | 11-026 | 11-027 |  |  |  |  |  | 09-026 |  |  |  |  | 11-038 | 08-043 |  |  |  |  |  |  |
| 142213133b |  | P-#2 Build Boxes and Associated Hardware Part B FY11 (Revised by Administrative CR 11-38) |  | 107d | 2011-05-02 | 2011-09-30 | 142213132, 9-110M FS+141d | 99d | 0d | PLABOR; SKLLD TRADE [24.11 h]; MECH ENG [24.82 h]; CONTRB UNIV LBR [10.64 h]; MECH TECH [297.84 h] | 21,903.39 | ELOUADRHIRI L | 1 | 1 |  | LATIFA E | 10-015 | 11-026 | 11-027 | 11 -035 | 13-002F |  |  |  | 09-026 |  |  |  |  | 11-038 | 08-043 |  |  |  |  |  |  |
| 142213062 |  | ODU Contract Peg Point #4 String and Test all wires on RII chamber #2 |  | 122d | 2011-07-01 | 2011-12-30 | 142213060 FS-85d | 106d | 0d | PROCUREMENT<$50K 60 NO ESCALATION; PROCUREMENT>$50K 69 NO ESCALATION | 91,829.27 | ELOUADRHIRI L | 1 | 1 |  | LATIFA E | 10-015 | 11-026 |  | 11 -035 | 13-002F |  |  |  | 09-026 |  |  |  |  |  |  |  |  | 11-010 |  |  |  |
| 142213064 |  | ODU Contract Peg Point #5 String and Test all wires on RII chamber #3 |  | 205d | 2011-07-01 | 2012-04-30 | 142213062 FS-122d | 106d | 0d | PROCUREMENT>$50K 69 NO ESCALATION | 71,371.95 | ELOUADRHIRI L | 1 | 1 |  | LATIFA E | 10-015 | 11-026 |  | 11 -035 | 13-002F |  |  |  | 09-026 |  |  |  |  |  |  |  |  | 11-010 |  |  |  |
| 142213012E |  | FY12 Travel (FWD Chambers) |  | 247d | 2011-10-03 | 2012-09-28 | 142213011E | 248d |  | TRAVEL | 18,754.1 | ELOUADRHIRI L | 1 | 1 |  | LATIFA E | 10-015 | 11-026 |  | 11 -035 | 13-002F | 07-024 |  |  |  |  |  |  |  |  |  |  |  |  |  |  |  |
| 142213085 |  | ISU Contract Phase 1c - Hire and train last 2 stringers, string wires and test chamber 2 |  | 98d | 2011-10-03 | 2012-02-29 | 142213080 FS-21d | 42d | 0d | PROCUREMENT<$50K 60 NO ESCALATION; PROCUREMENT>$50K 69 NO ESCALATION | 69,570 | ELOUADRHIRI L | 1 | 1 |  | LATIFA E | 10-015 | 11-026 |  | 11 -035 | 13-002F |  |  |  | 09-026 |  |  |  |  |  |  |  |  |  | 11-031 |  |  |
| 142213117Bb |  | P-#2 Proc Endplates & Frames LABOR Final FY12 |  | 206d | 2011-10-03 | 2012-08-01 | 142213117Ba | 60d | 0d | MECH DES [253.05 h]; MECH ENG [79.08 h]; MECH TECH [15.82 h] | 18,437.55 | ELOUADRHIRI L | 1 | 1 |  | LATIFA E | 10-015 | 11-026 |  | 11 -035 | 13-002F |  |  | APP | 09-026 |  |  |  |  |  |  |  | 11-001 |  |  | 12-001 |  |
| 142213133C |  | P-#2 Build Boxes and Associated Hardware Part B FY12 (Revised by Administrative CR 11-38) |  | 247d | 2011-10-03 | 2012-09-28 | 142213133b | 99d | 0d | MECH ENG [57.29 h]; CONTRB UNIV LBR [24.55 h]; MECH TECH [687.54 h]; PLABOR; SKLLD TRADE [55.66 h] | 52,172.06 | ELOUADRHIRI L | 1 | 1 |  | LATIFA E | 10-015 | 11-026 | 11-027 | 11 -035 | 13-002F |  |  |  | 09-026 |  |  |  |  | 11-038 | 08-043 |  |  |  |  |  | 12-053 |
| 142213144a |  | P-#2 String Chambers Part B FY12 |  | 141d | 2011-10-03 | 2012-04-30 | 142213144 | 139d | 12d | PLABOR; MECH TECH [490.1 h] | 98,995.56 | ELOUADRHIRI L | 1 | 1 |  | LATIFA E | 10-015 | 11-026 | 11-027 | 11 -035 | 13-002F |  |  |  | 09-026 |  |  |  | 09-012 |  | 08-043 |  |  |  |  | 12-001 |  |
| 142213232 |  | P-#3 Build Boxes and Associated Hardware FY12 |  | 247d | 2011-10-03 | 2012-09-28 | 9-120M, 142213217P, 142213220P | 309d | 0d | SCIENTIST [29.06 h]; MECH DES [25.83 h]; MECH ENG [69.42 h]; MECH TECH [104.61 h] | 12,812.76 | ELOUADRHIRI L | 1 | 1 |  | LATIFA E | 10-015 | 11-026 | 11-027 | 11 -035 | 13-002F |  |  |  | 09-026 |  |  |  |  |  |  |  |  |  |  |  | 12-053 |
| 142213235P |  | P-#3 Proc Cleanroom Fixtures and Equipment |  | 247d | 2011-10-03 | 2012-09-28 | 9-120M | 280d | 153d | PROCUREMENT<$50K 60 | 87,528.01 | ELOUADRHIRI L | 1 | 1 |  | LATIFA E | 10-015 | 11-026 | 11-027 | 11 -035 | 13-002F |  |  |  | 09-026 |  |  |  |  |  | 08-043 |  |  |  |  |  |  |
| 142213235a |  | P-#3 Build Stringing Fixtures, Machines and Platforms FY12 |  | 98d | 2011-10-03 | 2012-02-29 | 142213235 | 429d | 302d | MECH TECH [99.59 h]; MECH ENG [91.63 h]; MECH DES [199.19 h] | 20,445.86 | ELOUADRHIRI L | 1 | 1 |  | LATIFA E | 10-015 | 11-026 | 11-027 | 11 -035 | 13-002F |  |  |  | 09-026 |  |  |  |  |  | 08-043 |  |  |  |  | 12-001 |  |

Notes:
- 142213075: Explanation: Intentional Linear Curve
- 142213080: Explanation: Intentional Linear Curve
- 142213085: Explanation: Intentional Linear Curve

| ID | Activity | Type | Duration | Start | Finish | Predecessors | Total float | Free float | Calendar | Resources | Cost | RESP - Responsibility | STRT%COMP for CM EVM | FNSH%COMP for CM EVM | Milestone Level | CAM RESPONSIBLE | CR 08-043 | CR 09-026 | CR 10-015 | CR 11-026 | CR 11-035 | CR 13-002 | Advance Purchase Plan > 500K | CR 11-027 | CR 12-007 | CR 11-010 | CR 11-031 | CR 12-027 | CR 09-012 | CR 12-053 | CR 11-038 | CR 13-014 | ReBaseline Actuals Adjustment | Original Activity ID Rebaseline | Over Under Fixed | EVMS Reporting Codes | BOE Procurement | CR 13-015 | Post Rebaseline | Obligated Prior to Rebaseline | Pre Rebaseline Remaining Budget | BOE Labor | Previously In Progress | CR 14-001 | Activities with Steps | CR 13-010 |
| --- | --- | --- | --- | --- | --- | --- | --- | --- | --- | --- | --- | --- | --- | --- | --- | --- | --- | --- | --- | --- | --- | --- | --- | --- | --- | --- | --- | --- | --- | --- | --- | --- | --- | --- | --- | --- | --- | --- | --- | --- | --- | --- | --- | --- | --- | --- |
| 142213300M | P-#4 Constrction Start P-#4 | milestone | 0d | 2011-10-03 | 2011-10-03 | 9-120M | 62d | 0d |  |  |  | ELOUADRHIRI L | 1 | 1 | 6 | LATIFA E | 08-043 | 09-026 | 10-015 | 11-026 | 11 -035 | 13-002F |  |  |  |  |  |  |  |  |  |  |  |  |  |  |  |  |  |  |  |  |  |  |  |  |
| 142213317 | P-#4 Proc Endplates & Frames LABOR |  | 161d | 2011-10-03 | 2012-05-29 | 142213300M | 105d | 45d |  | CONTRB UNIV LBR [40 h]; MECH TECH [8 h] | 355.52 | ELOUADRHIRI L | 1 | 1 |  | LATIFA E |  | 09-026 | 10-015 | 11-026 | 11 -035 | 13-002F | APP |  |  |  |  |  |  |  |  |  |  |  |  |  |  |  |  |  |  |  |  |  |  |  |
| 142213320 | P-#4 Proc Box Assy. Fixtures LABOR |  | 121d | 2011-10-03 | 2012-04-02 | 142213300M | 374d |  |  | MECH TECH [8 h] | 355.52 | ELOUADRHIRI L | 1 | 1 |  | LATIFA E |  | 09-026 | 10-015 | 11-026 | 11 -035 | 13-002F | APP | 11-027 |  |  |  |  |  |  |  |  |  |  |  |  |  |  |  |  |  |  |  |  |  |  |
| 142213320P | P-#4 Proc Box Assy. Fixtures |  | 141d | 2011-10-03 | 2012-04-30 | 142213300M | 354d |  |  | PROCUREMENT<$50K 60 | 109.88 | ELOUADRHIRI L | 1 | 1 |  | LATIFA E |  | 09-026 | 10-015 | 11-026 | 11 -035 | 13-002F | APP | 11-027 |  |  |  |  |  |  |  |  |  |  |  |  |  |  |  |  |  |  |  |  |  |  |
| 142213322 | P-#4 Proc Wires, Pins and Feedthroughs LABOR |  | 130d | 2011-10-03 | 2012-04-13 | 142213300M | 365d |  |  | MECH TECH [8 h] | 355.52 | ELOUADRHIRI L | 1 | 1 |  | LATIFA E |  | 09-026 | 10-015 | 11-026 | 11 -035 | 13-002F | APP |  |  |  |  |  |  |  |  |  |  |  |  |  |  |  |  |  |  |  |  |  |  |  |
| 142213322P | P-#4 Proc Wires, Pins and Feedthroughs |  | 90d | 2011-10-03 | 2012-02-16 | 142213300M | 405d |  |  | PROCUREMENT<$50K 60 | 109.88 | ELOUADRHIRI L | 1 | 1 |  | LATIFA E |  | 09-026 | 10-015 | 11-026 | 11 -035 | 13-002F | APP |  |  |  |  |  |  |  |  |  |  |  |  |  |  |  |  |  |  |  |  |  |  |  |
| 142213330 | P-#4 Proc Circuit Boards LABOR |  | 21d | 2011-10-03 | 2011-10-31 | 142213300M | 288d | 268d |  | CONTRB UNIV LBR [33.6 h]; MECH TECH [1.87 h] | 83.1 | ELOUADRHIRI L | 1 | 1 |  | LATIFA E | 08-043 | 09-026 | 10-015 | 11-026 | 11 -035 | 13-002F | APP |  | 12-007 |  |  |  |  |  |  |  |  |  |  |  |  |  |  |  |  |  |  |  |  |  |
| 142213330P | P-#4 Proc Circuit Boards |  | 205d | 2011-10-03 | 2012-07-31 | 142213300M | 62d | 42d |  | PROCUREMENT<$50K 60; PROCUREMENT>$50K 69 | 179,465.95 | ELOUADRHIRI L | 1 | 1 |  | LATIFA E | 08-043 | 09-026 | 10-015 | 11-026 | 11 -035 | 13-002F | APP | 11-027 |  |  |  |  |  |  |  |  |  |  |  |  |  |  |  |  |  |  |  |  |  |  |
| 142213335 | P-#4 Build Stringing Fixtures, Machines and Platforms |  | 247d | 2011-10-03 | 2012-09-28 | 142213300M | 309d | 289d |  | MECH TECH [8 h] | 355.52 | ELOUADRHIRI L | 1 | 1 |  | LATIFA E | 08-043 | 09-026 | 10-015 | 11-026 | 11 -035 | 13-002F |  |  |  |  |  |  |  |  |  |  |  |  |  |  |  |  |  |  |  |  |  |  |  |  |
| 142213065 | ODU Contract Peg Point #6String and Test all wires on RII chamber #4 |  | 147d | 2012-01-03 | 2012-07-31 | 142213064 FS-83d | 106d | 0d |  | PROCUREMENT<$50K 60 NO ESCALATION; PROCUREMENT>$50K 69 NO ESCALATION | 69,389.79 | ELOUADRHIRI L | 1 | 1 |  | LATIFA E |  | 09-026 | 10-015 | 11-026 | 11 -035 | 13-002F |  |  |  | 11-010 |  |  |  |  |  |  |  |  |  |  |  |  |  |  |  |  |  |  |  |  |
| 142213066 | ODU Contract Peg Point #7 String and Test all wires on RII chamber #5 |  | 212d | 2012-01-03 | 2012-10-31 | 142213065 FS-147d | 106d | 0d |  | PROCUREMENT>$50K 69 NO ESCALATION | 61,371.95 | ELOUADRHIRI L | 1 | 1 |  | LATIFA E |  |  |  | 11-026 | 11 -035 | 13-002F |  |  |  | 11-010 |  |  |  |  |  |  |  |  |  |  |  |  |  |  |  |  |  |  |  |  |
| 142213330a | P-#4 Proc Circuit Boards LABOR Revised FY12 |  | 187d | 2012-01-05 | 2012-09-28 | 9-120M FS+60d | 20d | 0d |  | ELEC TECH [1503.2 h]; CONTRB UNIV LBR [110.4 h] | 66,336.22 | ELOUADRHIRI L | 1 | 1 |  | LATIFA E | 08-043 | 09-026 | 10-015 | 11-026 | 11 -035 | 13-002F | APP |  | 12-007 |  |  |  |  |  |  |  |  |  |  |  |  |  |  |  |  |  |  |  |  |  |
| 142213087 | ISU Contract Phase 2 - Install, tension, string wires and test chamber 3 |  | 141d | 2012-01-11 | 2012-07-31 | 142213085 FS-34d | 42d | 0d |  | PROCUREMENT<$50K 60 NO ESCALATION; PROCUREMENT>$50K 69 NO ESCALATION | 72,001 | ELOUADRHIRI L | 1 | 1 |  | LATIFA E |  | 09-026 | 10-015 | 11-026 | 11 -035 | 13-002F |  |  |  |  | 11-031 |  |  |  |  |  |  |  |  |  |  |  |  |  |  |  |  |  |  |  |
| 142213089 | ISU Contract Phase 3 - Install, tension, string wires and test chamber 4 |  | 164d | 2012-01-11 | 2012-08-31 | 142213087 FS-141d | 42d | 0d |  | PROCUREMENT>$50K 69 NO ESCALATION | 133,386 | ELOUADRHIRI L | 1 | 1 |  | LATIFA E |  | 09-026 | 10-015 | 11-026 | 11 -035 | 13-002F |  |  |  |  | 11-031 |  |  |  |  |  |  |  |  |  |  |  |  |  |  |  |  |  |  |  |
| 142213335P | P-#4 Proc Cleanroom Fixtures and Equipment Part A |  | 127d | 2012-04-02 | 2012-09-28 | 142213300M FS+120d | 309d | 289d |  | PROCUREMENT<$50K 60 | 23,889.06 | ELOUADRHIRI L | 1 | 1 |  | LATIFA E | 08-043 | 09-026 | 10-015 | 11-026 | 11 -035 | 13-002F |  | 11-027 |  |  |  | 12-027 |  |  |  |  |  |  |  |  |  |  |  |  |  |  |  |  |  |  |
| 142213242 | P-#3 String Chambers FY12 |  | 94d | 2012-05-17 | 2012-09-28 | 9-120M, 142213144a, 142213230P FS-30d, 142213230, 142213222P, 142213235a FS-247d, 142213232a FS-335d, 142213222, 142213235P FS-247d | 127d | 0d |  | PLABOR; MECH TECH [635.35 h] | 167,388.45 | ELOUADRHIRI L | 1 | 1 |  | LATIFA E | 08-043 | 09-026 | 10-015 | 11-026 | 11 -035 | 13-002F |  | 11-027 | 12-007 |  |  |  | 09-012 | 12-053 |  |  |  |  |  |  |  |  |  |  |  |  |  |  |  |  |
| 142213067 | ODU Contract Peg Point #8 String and Test all wires on RII chamber #6 |  | 144d | 2012-07-02 | 2013-01-31 | 142213066 FS-87d | 106d | 0d |  | PROCUREMENT<$50K 60 NO ESCALATION | 40,914.64 | ELOUADRHIRI L | 1 | 1 |  | LATIFA E |  |  |  | 11-026 | 11 -035 | 13-002F |  |  |  | 11-010 |  |  |  |  |  |  |  |  |  |  |  |  |  |  |  |  |  |  |  |  |
| 142213068 | ODU Contract Peg Point #9 Five RII Chambers fully tested |  | 184d | 2012-07-02 | 2013-03-29 | 142213067 FS-144d | 106d | 0d |  | PROCUREMENT>$50K 69 NO ESCALATION; PROCUREMENT<$50K 60 NO ESCALATION | 14,784 | ELOUADRHIRI L | 1 | 1 |  | LATIFA E |  |  |  | 11-026 | 11 -035 | 13-002F |  |  |  | 11-010 |  |  |  |  |  |  |  |  |  |  |  |  |  |  |  |  |  |  |  |  |
| 142213069 | ODU Contract Peg Point #10 Ship Final chamber to JLab |  | 206d | 2012-07-02 | 2013-04-30 | 142213068 FS-184d | 106d | 0d |  |  |  | ELOUADRHIRI L | 1 | 1 |  | LATIFA E |  | 09-026 | 10-015 | 11-026 | 11 -035 | 13-002F |  |  |  | 11-010 |  |  |  |  |  |  |  |  |  |  |  |  |  |  |  |  |  |  |  |  |
| 142213090 | ISU Contract Phase 4a - Install and tension chamber 5 |  | 56d | 2012-07-12 | 2012-09-28 | 142213089 FS-37d | 42d | 0d |  | PROCUREMENT<$50K 60 NO ESCALATION | 30,000 | ELOUADRHIRI L | 1 | 1 |  | LATIFA E |  | 09-026 | 10-015 | 11-026 | 11 -035 | 13-002F |  |  |  |  | 11-031 |  |  |  |  |  |  |  |  |  |  |  |  |  |  |  |  |  |  |  |
| 142213095 | ISU Contract Phase 5a - Install and tension chamber 6 |  | 56d | 2012-07-12 | 2012-09-28 | 142213092 FS-136d | 42d | 0d |  | PROCUREMENT<$50K 60 NO ESCALATION; PROCUREMENT>$50K 69 NO ESCALATION | 33,346 | ELOUADRHIRI L | 1 | 1 |  | LATIFA E |  | 09-026 | 10-015 | 11-026 | 11 -035 | 13-002F |  |  |  |  | 11-031 |  |  |  |  |  |  |  |  |  |  |  |  |  |  |  |  |  |  |  |
| 142213332 | P-#4 Build Boxes and Associated Hardware FY12 |  | 41d | 2012-08-02 | 2012-09-28 | 142213117Bb, 142213317 | 60d | 0d |  | MECH ENG [7.63 h]; MECH TECH [7.63 h] | 874.1 | ELOUADRHIRI L | 1 | 1 |  | LATIFA E |  | 09-026 | 10-015 | 11-026 | 11 -035 | 13-002F |  |  |  |  |  |  |  | 12-053 |  |  |  |  |  |  |  |  |  |  |  |  |  |  |  |  |
| 142213092 | ISU Contract Phase 4b - String wires and test chamber 5 |  | 80d | 2012-10-01 | 2013-01-31 | 142213090 | 42d | 0d |  | PROCUREMENT<$50K 60 NO ESCALATION | 42,001 | ELOUADRHIRI L | 1 | 1 |  | LATIFA E |  | 09-026 | 10-015 | 11-026 | 11 -035 | 13-002F |  |  |  |  | 11-031 |  |  |  |  |  |  |  |  |  |  |  |  |  |  |  |  |  |  |  |
| 142213097 | ISU Contract Phase 5b - String wires and test chamber 6 |  | 99d | 2012-10-01 | 2013-02-28 | 142213095 | 42d | 0d |  | PROCUREMENT<$50K 60 NO ESCALATION; PROCUREMENT>$50K 69 NO ESCALATION | 100,040 | ELOUADRHIRI L | 1 | 1 |  | LATIFA E |  | 09-026 | 10-015 | 11-026 | 11 -035 | 13-002F |  |  |  |  | 11-031 |  |  |  |  |  |  |  |  |  |  |  |  |  |  |  |  |  |  |  |
| 142213100 | ISU Contract Phase 6 - Ship chambers, fixtures and equipment to JLab |  | 206d | 2012-10-01 | 2013-07-31 | 142213097 FS-99d | 42d | 0d |  | PROCUREMENT>$50K 69 NO ESCALATION | 27,939 | ELOUADRHIRI L | 1 | 1 |  | LATIFA E |  | 09-026 | 10-015 | 11-026 | 11 -035 | 13-002F |  |  |  |  | 11-031 |  |  |  |  |  |  |  |  |  |  |  |  |  |  |  |  |  |  |  |
| 142213133Ca | P-#2 Build Boxes and Associated Hardware Part B FY13 |  | 208d | 2012-10-01 | 2013-08-02 | 142213133C | 99d | 79d |  | MECH ENG [48.25 h]; CONTRB UNIV LBR [20.68 h]; MECH TECH [578.98 h]; PLABOR; SKLLD TRADE [46.87 h] | 45,337.84 | ELOUADRHIRI L | 1 | 1 |  | LATIFA E | 08-043 | 09-026 | 10-015 | 11-026 | 11 -035 | 13-002F |  | 11-027 |  |  |  |  |  | 12-053 | 11-038 |  |  |  |  |  |  |  |  |  |  |  |  |  |  |  |
| 142213232a | P-#3 Build Boxes and Associated Hardware FY13 |  | 59d | 2012-10-01 | 2012-12-31 | 142213232 | 309d | 182d |  | SCIENTIST [6.94 h]; MECH DES [6.17 h]; MECH ENG [16.58 h]; MECH TECH [24.99 h] | 3,158.13 | ELOUADRHIRI L | 1 | 1 |  | LATIFA E |  | 09-026 | 10-015 | 11-026 | 11 -035 | 13-002F |  | 11-027 |  |  |  |  |  | 12-053 |  |  |  |  |  |  |  |  |  |  |  |  |  |  |  |  |
| 142213242a | P-#3 String Chambers FY13 |  | 121d | 2012-10-01 | 2013-04-01 | 142213242 | 127d |  |  | PLABOR; MECH TECH [817.85 h] | 222,343.74 | ELOUADRHIRI L | 1 | 1 |  | LATIFA E | 08-043 | 09-026 | 10-015 | 11-026 | 11 -035 | 13-002F |  | 11-027 | 12-007 |  |  |  | 09-012 | 12-053 |  |  |  |  |  |  |  |  |  |  |  |  |  |  |  |  |
| 142213330PA | P-#5 Proc Circuit Boards |  | 162d | 2012-10-01 | 2013-05-29 | 9-130M, 142213330P | 20d | 0d |  | PROCUREMENT>$50K 69; PROCUREMENT<$50K 60 | 185,190.91 | ELOUADRHIRI L | 1 | 1 |  | LATIFA E | 08-043 | 09-026 | 10-015 | 11-026 | 11 -035 | 13-002F | APP | 11-027 |  |  |  | 12-027 |  |  |  |  |  |  |  |  |  |  |  |  |  |  |  |  |  |  |
| 142213330b | P-#4 Proc Circuit Boards LABOR Revised FY13 |  | 228d | 2012-10-01 | 2013-08-30 | 142213330a | 20d |  |  | ELEC TECH [830.36 h] | 37,814.59 | ELOUADRHIRI L | 1 | 1 |  | LATIFA E | 08-043 | 09-026 | 10-015 | 11-026 | 11 -035 | 13-002F | APP |  | 12-007 |  |  |  |  |  |  | 13-014 |  |  |  |  |  |  |  |  |  |  |  |  |  |  |
| 142213332a | P-#4 Build Boxes and Associated Hardware FY13 |  | 2d | 2012-10-01 | 2012-10-02 | 142213332 | 60d | 40d |  | MECH ENG [0.37 h]; MECH TECH [0.37 h] | 43.74 | ELOUADRHIRI L | 1 | 1 |  | LATIFA E |  | 09-026 | 10-015 | 11-026 | 11 -035 | 13-002F |  |  |  |  |  |  |  | 12-053 |  |  |  |  |  |  |  |  |  |  |  |  |  |  |  |  |
| 142213342 | P-#4 String Chambers |  | 186d | 2012-11-30 | 2013-08-30 | 142213133Ca FS-245d, 142213332a, 142213300M, 142213132, 142213133 FS-245d, 142213330P, 142213335P FS-247d, 142213330, 142213330PA FS-120d, 142213335 FS-247d | 20d |  |  | PLABOR; MECH TECH [1098.76 h] | 331,945.14 | ELOUADRHIRI L | 1 | 1 |  | LATIFA E | 08-043 | 09-026 | 10-015 | 11-026 | 11 -035 | 13-002F |  |  | 12-007 |  |  | 12-027 | 09-012 |  |  | 13-014 |  |  |  |  |  |  |  |  |  |  |  |  |  |  |
| 142213360 | Re-Baseline Actuals Adjustment |  | 1d | 2013-08-30 | 2013-08-30 | 9-130M FS+227d | 20d |  |  | PROCUREMENT>$50K 69 NO ESCALATION | -162,969.92 | ELOUADRHIRI L | 1 | 1 |  | LATIFA E |  |  |  |  |  |  |  |  |  |  |  |  |  |  |  | 13-014 | ADJ |  |  |  |  |  |  |  |  |  |  |  |  |  |
| 242213073 | ODU Contract Mount Electronics on Chambers |  | 267d | 2013-09-03 | 2014-09-30 | 9-130M FS+228d | 285d | 120d | 8/5 M-F w/JLAB Holidays ReBaseline | PROCUREMENT>$50K 69 NO ESCALATION; PROCUREMENT<$50K 60 NO ESCALATION | 122,486.85 | ELOUADRHIRI L | 1 | 1 |  | LATIFA E |  |  |  | 11-026 | 11 -035 | 13-002F |  |  |  | 11-010 |  |  |  |  |  |  |  | 242213073 | y | D | OB | 13-015 | PR | OB |  |  |  |  |  |  |
| 242213092 | ISU Contract Phase 4b - String wires and test chamber 5 |  | 98d | 2013-09-03 | 2014-01-31 | 9-130M FS+228d | 384d | 0d | 8/5 M-F w/JLAB Holidays ReBaseline | PROCUREMENT<$50K 60 NO ESCALATION | 16,334.19 | ELOUADRHIRI L | 1 | 1 |  | LATIFA E |  | 09-026 | 10-015 | 11-026 | 11 -035 | 13-002F |  |  |  |  | 11-031 |  |  |  |  |  |  | 242213092 | y | D | OB | 13-015 | PR | OB |  |  |  |  |  |  |
| 242213097 | ISU Contract Phase 5b - String wires and test chamber 6 |  | 98d | 2013-09-03 | 2014-01-31 | 242213092 FS-98d | 384d | 0d | 8/5 M-F w/JLAB Holidays ReBaseline | PROCUREMENT<$50K 60 NO ESCALATION; PROCUREMENT>$50K 69 NO ESCALATION | 38,905.56 | ELOUADRHIRI L | 1 | 1 |  | LATIFA E |  | 09-026 | 10-015 | 11-026 | 11 -035 | 13-002F |  |  |  |  | 11-031 |  |  |  |  |  |  | 242213097 | y | D | OB | 13-015 | PR | OB |  |  |  |  |  |  |
| 242213100 | ISU Contract Phase 6 - Ship chambers, fixtures and equipment to JLab |  | 161d | 2013-09-03 | 2014-04-30 | 242213097 FS-98d | 384d | 0d | 8/5 M-F w/JLAB Holidays ReBaseline | PROCUREMENT>$50K 69 NO ESCALATION | 88,172.38 | ELOUADRHIRI L | 1 | 1 |  | LATIFA E |  | 09-026 | 10-015 | 11-026 | 11 -035 | 13-002F |  |  |  |  | 11-031 |  |  |  |  |  |  | 242213100 | y | D | OB | 13-015 | PR | OB |  |  |  |  |  |  |
| 242213133C | P-#2 Build Boxes and Associated Hardware FY13 |  | 20d | 2013-09-03 | 2013-09-30 | 9-130M FS+228d | 337d | 0d | 8/5 M-F w/JLAB Holidays ReBaseline | MECH TECH [1.52 h] | 69.71 | ELOUADRHIRI L | 1 | 1 |  | LATIFA E | 08-043 | 09-026 | 10-015 | 11-026 | 11 -035 | 13-002F |  | 11-027 |  |  |  |  |  | 12-053 | 11-038 |  |  | 242213133C |  | H |  | 13-015 | PR |  | 19225.54 | PE | Review |  |  |  |
| 242213232 | P-#3 Build Boxes and Associated Hardware FY13 |  | 20d | 2013-09-03 | 2013-09-30 | 9-130M FS+228d | 411d | 0d | 8/5 M-F w/JLAB Holidays ReBaseline | MECH TECH [1.86 h] | 85.3 | ELOUADRHIRI L | 1 | 1 |  | LATIFA E |  | 09-026 | 10-015 | 11-026 | 11 -035 | 13-002F |  | 11-027 |  |  |  |  |  | 12-053 |  |  |  | 242213232 |  | H |  | 13-015 | PR |  | 7506.32 | PE | Review |  |  |  |
| 242213330PA | Proc LVHV Distribution Cables and Boxes |  | 387d | 2013-09-03 | 2015-04-01 | 9-130M FS+228d | 165d | 0d | 8/5 M-F w/JLAB Holidays ReBaseline | PROCUREMENT>$50K 69 NO ESCALATION FY14; PROCUREMENT<$50K 60 NO ESCALATION FY14 | 65,000 | ELOUADRHIRI L | 1 | 1 |  | LATIFA E | 08-043 | 09-026 | 10-015 | 11-026 | 11 -035 | 13-002F | APP | 11-027 |  |  |  | 12-027 |  |  |  |  |  | 242213330PA |  | D | EJ | 13-015 | PR |  |  |  |  |  |  |  |
| 242213331 | HV Dist Box Construction and Testing Labor |  | 387d | 2013-09-03 | 2015-04-01 | 9-130M FS+228d | 165d | 0d | 8/5 M-F w/JLAB Holidays ReBaseline | PROCUREMENT<$50K 60 NO ESCALATION FY14 | 3,900 | ELOUADRHIRI L | 1 | 1 |  | LATIFA E | 08-043 | 09-026 | 10-015 | 11-026 | 11 -035 | 13-002F | APP | 11-027 |  |  |  |  |  |  |  |  |  | 242213331 |  | U | EJ | 13-015 | PR |  |  |  |  |  |  |  |
| 242213335Pa | P-#4 Proc Cleanroom Fixtures and Equipment Part B |  | 19d | 2013-09-03 | 2013-09-27 | 9-130M FS+228d | 457d | 228d | 8/5 M-F w/JLAB Holidays ReBaseline | PROCUREMENT<$50K 60 | 197.28 | ELOUADRHIRI L | 1 | 1 |  | LATIFA E | 08-043 | 09-026 | 10-015 | 11-026 | 11 -035 | 13-002F |  | 11-027 |  |  |  | 12-027 |  |  |  |  |  | 242213335Pa | y | D | OB | 13-015 | PR | OB |  |  |  |  |  |  |
| 242213342 | P-#4 String Chambers FY13 |  | 20d | 2013-09-03 | 2013-09-30 | 242213133Ca FS-289d, 9-130M FS+228d, 242213335Pa FS-247d, 242213133C FS-289d | 229d | 0d | 8/5 M-F w/JLAB Holidays ReBaseline | ELEC TECH [15.41 h]; MECH TECH [30.81 h] | 2,114.72 | ELOUADRHIRI L | 1 | 1 |  | LATIFA E | 08-043 | 09-026 | 10-015 | 11-026 | 11 -035 | 13-002F |  |  | 12-007 |  |  | 12-027 | 09-012 |  |  |  |  | 242213342 |  | U |  | 13-015 | PR |  | 403463.31 | PE | Review |  |  |  |
| 242213133Ca | P-#2 Build Boxes and Associated Hardware FY14 |  | 161d | 2013-10-01 | 2014-05-29 | 9-130M FS+228d, 242213133C | 337d | 108d | 8/5 M-F w/JLAB Holidays ReBaseline | MECH TECH [12.26 h] | 580.14 | ELOUADRHIRI L | 1 | 1 |  | LATIFA E | 08-043 | 09-026 | 10-015 | 11-026 | 11 -035 | 13-002F |  | 11-027 |  |  |  |  |  | 12-053 | 11-038 |  |  | 242213133C |  | H |  | 13-015 | PR |  | 19225.54 | PE | Review | 14-001 |  |  |
| 242213232a | P-#3 Build Boxes and Associated Hardware FY14 |  | 121d | 2013-10-01 | 2014-04-02 | 242213232, 9-130M FS+228d | 411d | 246d | 8/5 M-F w/JLAB Holidays ReBaseline | MECH TECH [11.28 h] | 533.77 | ELOUADRHIRI L | 1 | 1 |  | LATIFA E |  | 09-026 | 10-015 | 11-026 | 11 -035 | 13-002F |  | 11-027 |  |  |  |  |  | 12-053 |  |  |  | 242213232 |  | H |  | 13-015 | PR |  | 7506.32 | PE | Review | 14-001 |  |  |
| 242213342a | P-#4 String Chambers FY14 |  | 61d | 2013-10-01 | 2014-01-07 | 242213133C FS-289d, 242213133Ca FS-289d, 9-130M FS+228d, 242213335Pa FS-247d, 242213342 | 229d | 0d | 8/5 M-F w/JLAB Holidays ReBaseline | ELEC TECH [46.99 h]; MECH TECH [93.99 h] | 6,655.67 | ELOUADRHIRI L | 1 | 1 |  | LATIFA E | 08-043 | 09-026 | 10-015 | 11-026 | 11 -035 | 13-002F |  |  | 12-007 |  |  | 12-027 | 09-012 |  |  |  |  | 242213342 |  | U |  | 13-015 | PR |  | 403463.31 | PE | Review | 14-001 |  |  |
| 242213078 | De-Obligation of ODU Contract |  | 1d | 2013-10-15 | 2013-10-15 | 9-140M FS+10d | 521d | 356d | 8/5 M-F w/JLAB Holidays ReBaseline | PROCUREMENT>$50K 69 NO ESCALATION; PROCUREMENT<$50K 60 NO ESCALATION | -47,486.85 | ELOUADRHIRI L | 1 | 1 |  | LATIFA E |  |  |  | 11-026 | 11 -035 | 13-002F |  |  |  | 11-010 |  |  |  |  |  |  |  | 242213073 |  | D | OB | 13-015 | PR |  |  |  |  |  |  |  |
| 242213347 | P-#5 String Chambers |  | 242d | 2014-01-08 | 2014-12-19 | 242213342a, 242213342 | 229d | 64d | 8/5 M-F w/JLAB Holidays ReBaseline | ELEC TECH [1827.9 h]; MECH TECH [2741.86 h] | 215,637.84 | ELOUADRHIRI L | 1 | 1 |  | LATIFA E | 08-043 | 09-026 | 10-015 | 11-026 | 11 -035 | 13-002F |  | 11-027 |  |  |  | 12-027 | 09-012 |  |  |  |  | 242213347 |  | S | PE | 13-015 | PR |  |  | PE |  | 14-001 | ST | 13-010 |
| 242213355M | Chambers Complete | milestone | 0d | 2015-04-01 | 2015-04-01 | 242213330PA, 242213073, 242213347, 242213100, 242213078, 242213232a, 242213342a, 242213232, 242213331, 242213342 | 165d | 0d | 8/5 M-F w/JLAB Holidays ReBaseline |  |  | ELOUADRHIRI L | 1 | 1 |  | LATIFA E |  | 09-026 | 10-015 | 11-026 | 11 -035 | 13-002F |  |  |  |  |  | 12-027 |  |  |  |  |  | 242213355M |  | M |  | 13-015 | PR |  |  |  |  |  |  |  |

Notes:
- 142213330a: Steps: STB - Receive approved R1 end plate files from ME group; STB - copy and verify R1 schematics; STB - R1 component placement and optimization; STB - R1 board layout (multilayer) & design rule check; STB - Create R1 manufacturing files; STB - order all R1 components; STB - Receive R1 bare boards and send for solder/assembly; STB - Receive R1 assembled boards and bench test; STB - R1 STBs ready to be installed on drift chamber; HVB - copy and verify R1 schematics; HVB - R1 component placement and optimization; HVB - R1 board layout (2-layer) & design rule check; HVB - Create R1 manufacturing files; HVB - order all R1 components; HVB - Receive R1 bare boards and send for solder/assembly; HVB - Receive R1 assembled boards and HiPot bench test; HVB - R1 HVBs ready to be installed on drift chamber
- 142213087: Explanation: Intentional Linear Curve
- 142213089: Explanation: Intentional Linear Curve
- 142213090: Explanation: Intentional Linear Curve
- 142213095: Explanation: Intentional Linear Curve
- 142213092: Explanation: Intentional Linear Curve
- 142213097: Explanation: Intentional Linear Curve
- 142213330b: Steps: STB - Receive approved R3 end plate files from ME group; STB - copy and verify R3 schematics; STB - R3 component placement and optimization; STB - R3 board layout (multilayer) & design rule check; STB - Create R3 manufacturing files; STB - order all R3 components; STB - Receive R3 bare boards and send for solder/assembly; STB - Receive R3 assembled boards and bench test; STB - R3 STBs ready to be installed on drift chamber; HVB - copy and verify R3 schematics; HVB - R3 component placement and optimization; HVB - R3 board layout (2-layer) & design rule check; HVB - Create R3 manufacturing files; HVB - order all R3 components; HVB - Receive R3 bare boards and send for solder/assembly; HVB - Receive R3 assembled boards and HiPot bench test; HVB - R3 HVBs ready to be installed on drift chamber
- 242213092: Explanation: Intentional Linear Curve
- 242213097: Explanation: Intentional Linear Curve
- 242213347: Steps: String and test all SL5 sense wires on 5th RIII chamber; String and test all SL6 sense wires on 5th RIII chamber; Re-Test all wires on 5th RIII chamber; Pot crimp pins on 5th RIII chamber; Survey and fiducialize 5th RIII chamber; Install gas window, Instrument 5th RIII Chamber; Install 6th RIII chamber on stringing fixture; Install 6th RIII pre-tension harware; String and test all SL6 field wires on 6th RIII chamber; String and test all SL5 field wires on 6th RIII chamber; String and test all SL5 sense wires on 6th RIII chamber; String and test all SL6 sense wires on 6th RIII chamber; Re-Test all wires on 6th RIII chamber; Pot crimp pins on 6th RIII chamber; Survey and fiducialize 6th RIII chamber; Install gas window, Instrument 6th RIII Chamber; Survey/fiducialize all RI chambers????????; transport RI chambers to hall; finish any remaining chamber stringing tasks; transport RII chambers to hall; test RII chambers; Install RII chambers; test RI chambers; Install RI chambers; transport RIII chambers to hall; test RIII chambers; Install RIII chambers

| ID | WBS | Activity | Type | Duration | Start | Finish | Predecessors | Total float | Free float | Resources | Cost | RESP - Responsibility | STRT%COMP for CM EVM | FNSH%COMP for CM EVM | Milestone Level | CAM RESPONSIBLE | CR 10-014 | CR 11-026 | CR 11-035 | CR 13-002 | Advance Purchase Plan > 500K | CR 10-011 | CR 12-007 | CR 12-054 | CR 10-060 | CR 11-001 | CR 12-001 |
| --- | --- | --- | --- | --- | --- | --- | --- | --- | --- | --- | --- | --- | --- | --- | --- | --- | --- | --- | --- | --- | --- | --- | --- | --- | --- | --- | --- |
|  | 2 | **1.4.2.2.2 CALORIMETRY** |  |  | 2009-10-01 | 2014-11-04 |  |  |  |  |  |  |  |  |  |  |  |  |  |  |  |  |  |  |  |  |  |
|  | 1 | **1.4.2.2.2.1 CENTRAL CALORIMETER** |  |  |  |  |  |  |  |  |  |  |  |  |  |  |  |  |  |  |  |  |  |  |  |  |  |
|  | 2 | **1.4.2.2.2.2 COIL CALORIMETER** |  |  |  |  |  |  |  |  |  |  |  |  |  |  |  |  |  |  |  |  |  |  |  |  |  |
|  | 3 | **1.4.2.2.2.3 FORWARD CALORIMETER** |  |  | 2009-10-01 | 2014-11-04 |  |  |  |  |  |  |  |  |  |  |  |  |  |  |  |  |  |  |  |  |  |
| 142223000M |  | EC-P-#1 Constr Start (FWD CAL) | milestone | 0d | 2009-10-01 | 2009-10-01 | 1222223040, 9-100M, 1222223041M | 621d | 0d |  |  | ELOUADRHIRI L | 1 | 1 | 6 | LATIFA E | 10-014 | 11-026 | 11 -035 | 13-002F |  |  |  |  |  |  |  |
| 142223005 |  | EC-P-#1 Prcrmnt Prep for Assy box (FWD CAL) |  | 20d | 2009-10-01 | 2009-10-28 | 142223000M | 621d | 0d | MECH DES [40 h]; MECH ENG [40 h]; MECH TECH [120 h]; SCIENTIST [40 h] | 12,104.8 | ELOUADRHIRI L | 1 | 1 |  | LATIFA E | 10-014 | 11-026 | 11 -035 | 13-002F |  |  |  |  |  |  |  |
| 142223010 |  | EC-P-#1 Prcrmnt Prep for Wave Shifting Fibers (FWD CAL) |  | 20d | 2009-10-01 | 2009-10-28 | 142223005 FS-20d, 142223000M | 621d | 40d |  |  | ELOUADRHIRI L | 1 | 1 |  | LATIFA E | 10-014 | 11-026 | 11 -035 | 13-002F |  |  |  |  |  |  |  |
| 142223015 |  | EC-P-#1 Prcrmnt Prep for PMTs (FWD CAL) |  | 20d | 2009-10-01 | 2009-10-28 | 142223000M | 846d | 40d |  |  | ELOUADRHIRI L | 1 | 1 |  | LATIFA E | 10-014 | 11-026 | 11 -035 | 13-002F |  |  |  |  |  |  |  |
| 142223020 |  | EC-P-#1 Prcrmnt Prep for Light Guides & Accessr's (FWD CAL) |  | 20d | 2009-10-01 | 2009-10-28 | 142223000M | 891d | 40d |  |  | ELOUADRHIRI L | 1 | 1 |  | LATIFA E | 10-014 | 11-026 | 11 -035 | 13-002F |  |  |  |  |  |  |  |
| 142223012 |  | EC-P-#1 Vend Fab of Wave Shifting Fibers (FWD CAL) |  | 175d | 2010-01-05 | 2010-09-13 | 9-100M FS+60d, 142223010 | 581d | 73d | PROCUREMENT>$50K 69; SCIENTIST [20 h] | 2,192.59 | ELOUADRHIRI L | 1 | 1 |  | LATIFA E | 10-014 | 11-026 | 11 -035 | 13-002F | APP | 10-011 |  |  |  |  |  |
| 142223017 |  | EC-P-#1 Vend Fab of PMTs (FWD CAL) |  | 125d | 2010-01-05 | 2010-07-01 | 142223015, 9-100M FS+60d | 806d |  | MECH DES [40 h]; MECH ENG [40 h]; MECH TECH [40 h]; SCIENTIST [100 h]; ELEC TECH [320 h] | 26,008.2 | ELOUADRHIRI L | 1 | 1 |  | LATIFA E | 10-014 | 11-026 | 11 -035 | 13-002F | APP | 10-011 |  |  |  |  |  |
| 142223022 |  | EC-P-#1 Vend Fab of Light Guides & Accessr's (FWD CAL) |  | 80d | 2010-01-05 | 2010-04-28 | 9-100M FS+60d, 142223020 | 851d |  | SCIENTIST [20 h]; PROCUREMENT<$50K 60; PROCUREMENT>$50K 69 | 64,835.99 | ELOUADRHIRI L | 1 | 1 |  | LATIFA E | 10-014 | 11-026 | 11 -035 | 13-002F | APP |  |  |  |  |  |  |
| 142223100M |  | PCAL Manufacturing Preparation - Milestone | milestone | 0d | 2010-04-01 | 2010-04-01 | 9-100M FS+120d | 560d | 0d |  |  | ELOUADRHIRI L | 1 | 1 |  | LATIFA E | 10-014 | 11-026 | 11 -035 | 13-002F |  |  |  |  |  |  |  |
| 142223105 |  | Scintillator Procurement |  | 66d | 2010-04-01 | 2010-07-02 | 142223100M, 9-100M FS+120d | 560d | 0d | PROCUREMENT<$50K 60; PROCUREMENT>$50K 69 | 97,807.41 | ELOUADRHIRI L | 1 | 1 |  | LATIFA E | 10-014 | 11-026 | 11 -035 | 13-002F |  |  |  |  |  |  |  |
| 142223185 |  | Complete Manufacturing Drawings for Box Assy |  | 33d | 2010-04-15 | 2010-06-01 | 9-100M FS+130d | 190d | 0d | VISTNG USERS [200 h]; PD UNIV STAFF [102.8 h] | 9,054.76 | ELOUADRHIRI L | 1 | 1 |  | LATIFA E | 10-014 | 11-026 | 11 -035 | 13-002F |  |  | 12-007 | 12-054F |  |  |  |
| 142223195 |  | Prepare workspace |  | 21d | 2010-05-03 | 2010-06-01 | 9-100M FS+142d | 317d | 0d | MECH TECH [160 h]; VISTNG USERS [160 h]; PD UNIV STUDNT [40 h]; CONTRB UNIV LBR [400 h] | 9,983.2 | ELOUADRHIRI L | 1 | 1 |  | LATIFA E | 10-014 | 11-026 | 11 -035 | 13-002F |  |  | 12-007 |  |  |  |  |
| 142223318 |  | Procurement- PMT Housing Components |  | 168d | 2010-05-03 | 2011-01-06 | 9-100M FS+142d | 278d | 72d | PROCUREMENT<$50K 60 NO ESCALATION FY11 | 40,000 | ELOUADRHIRI L | 1 | 1 |  | LATIFA E | 10-014 | 11-026 | 11 -035 | 13-002F |  |  | 12-007 |  |  |  |  |
| 142223110 |  | W&M - Prepare workspace |  | 11d | 2010-05-06 | 2010-05-20 | 142223105 FS-41d | 560d | 0d |  |  | ELOUADRHIRI L | 1 | 1 |  | LATIFA E | 10-014 | 11-026 | 11 -035 | 13-002F |  |  |  |  |  |  |  |
| 142223193 |  | Procurement of lead sheets |  | 404d | 2010-05-14 | 2012-01-03 | 9-100M FS+151d | 248d | 58d | PROCUREMENT<$50K 60 NO ESCALATION FY11; PROCUREMENT>$50K 69 NO ESCALATION FY11 | 90,000 | ELOUADRHIRI L | 1 | 1 |  | LATIFA E | 10-014 | 11-026 | 11 -035 | 13-002F |  |  | 12-007 | 12-054F |  |  |  |
| 142223115 |  | Scintillator Processing |  | 89d | 2010-05-21 | 2010-09-27 | 142223110, 142223105 FS-65d | 560d | 7d | MECH TECH [120 h] | 5,008.8 | ELOUADRHIRI L | 1 | 1 |  | LATIFA E | 10-014 | 11-026 | 11 -035 | 13-002F |  |  |  |  |  |  |  |
| 142223120 |  | W&M NSF - Fiber procurement |  | 275d | 2010-06-02 | 2011-07-11 | 142223115 FS-89d, 9-100M FS+163d | 553d |  |  |  | ELOUADRHIRI L | 1 | 1 |  | LATIFA E | 10-014 | 11-026 | 11 -035 | 13-002F |  |  |  |  |  |  |  |
| 142223186 |  | Issue PRs and Review Bids |  | 21d | 2010-06-02 | 2010-06-30 | 142223185 | 190d | 0d | VISTNG USERS [40 h]; MECH DES [40 h]; MECH ENG [40 h]; PD UNIV STAFF [40 h] | 7,280.4 | ELOUADRHIRI L | 1 | 1 |  | LATIFA E | 10-014 | 11-026 | 11 -035 | 13-002F |  |  | 12-007 | 12-054F |  |  |  |
| 142223316 |  | JMU PMT and Divider assembly and test |  | 391d | 2010-06-03 | 2012-01-03 | 9-100M FS+164d | 278d | 72d |  |  | ELOUADRHIRI L | 1 | 1 |  | LATIFA E | 10-014 | 11-026 | 11 -035 | 13-002F |  |  | 12-007 |  |  |  |  |
| 142223320 |  | Prepare workspace |  | 31d | 2010-06-30 | 2010-08-12 | 142223195 FS+20d | 317d | 111d | VISTNG USERS [248 h]; PD UNIV STUDNT [120 h]; MECH TECH [124 h]; CONTRB UNIV LBR [360 h] | 10,879.36 | ELOUADRHIRI L | 1 | 1 |  | LATIFA E | 10-014 | 11-026 | 11 -035 | 13-002F |  |  | 12-007 |  |  |  |  |
| 142223194 |  | FCAL Prepare EEL 125 Room & Floors |  | 64d | 2010-07-01 | 2010-09-30 | 9-100M FS+184d | 190d | 0d | MECH TECH [958.4 h] | 40,003.62 | ELOUADRHIRI L | 1 | 1 |  | LATIFA E |  | 11-026 | 11 -035 | 13-002F |  |  | 12-007 | 12-054F | 10-060 |  |  |
| 142223200 |  | Prepare Components Module 1 FY10 |  | 20d | 2010-09-02 | 2010-09-30 | 142223194 FS-20d, 142223193 FS-385d, 142223192 FS-150d, 142223191 FS-150d, 142223190 FS-150d | 190d | 0d | VISTNG USERS [48.89 h]; MECH TECH [48.89 h]; SUPPLIES & MATERIALS; CONTRB UNIV LBR [222.22 h]; PD UNIV STUDNT [22.22 h] | 5,928.44 | ELOUADRHIRI L | 1 | 1 |  | LATIFA E | 10-014 | 11-026 | 11 -035 | 13-002F |  |  | 12-007 | 12-054F |  | 11-001 |  |
| 142223317 |  | Fiber Polisher FY10 |  | 19d | 2010-09-03 | 2010-09-30 | 9-100M FS+229d | 288d | 0d | MSHOP | 9,500 | ELOUADRHIRI L | 1 | 1 |  | LATIFA E | 10-014 | 11-026 | 11 -035 | 13-002F |  |  | 12-007 |  |  | 11-001 |  |
| 142223190 |  | Procurement of retainers and PMT supports |  | 130d | 2010-10-01 | 2011-04-14 | 142223186 FS+64d, 142223185 | 190d | 0d | PROCUREMENT<$50K 60; PROCUREMENT>$50K 69 | 123,828 | ELOUADRHIRI L | 1 | 1 |  | LATIFA E | 10-014 | 11-026 | 11 -035 | 13-002F |  |  | 12-007 | 12-054F |  |  |  |
| 142223191 |  | Procurement of box sidewalls |  | 130d | 2010-10-01 | 2011-04-14 | 142223186 FS+64d | 190d | 0d | PROCUREMENT>$50K 69; PROCUREMENT<$50K 60 | 154,785 | ELOUADRHIRI L | 1 | 1 |  | LATIFA E | 10-014 | 11-026 | 11 -035 | 13-002F |  |  | 12-007 | 12-054F |  |  |  |
| 142223192 |  | Procurement of box windows |  | 130d | 2010-10-01 | 2011-04-14 | 142223186 FS+64d | 190d | 0d | PROCUREMENT>$50K 69; PROCUREMENT<$50K 60 | 92,871 | ELOUADRHIRI L | 1 | 1 |  | LATIFA E | 10-014 | 11-026 | 11 -035 | 13-002F |  |  | 12-007 | 12-054F |  |  |  |
| 142223200a |  | Prepare Components Module 1 FY11 |  | 16d | 2010-10-01 | 2010-10-22 | 142223200 | 190d | 0d | MECH TECH [39.11 h]; SUPPLIES & MATERIALS; CONTRB UNIV LBR [177.78 h]; PD UNIV STUDNT [17.78 h]; VISTNG USERS [39.11 h] | 4,893.96 | ELOUADRHIRI L | 1 | 1 |  | LATIFA E | 10-014 | 11-026 | 11 -035 | 13-002F |  |  | 12-007 | 12-054F |  | 11-001 |  |
| 142223317a |  | Fiber Polisher FY11 |  | 1d | 2010-10-01 | 2010-10-01 | 142223317 | 288d | 82d | MSHOP | 515.95 | ELOUADRHIRI L | 1 | 1 |  | LATIFA E | 10-014 | 11-026 | 11 -035 | 13-002F |  |  | 12-007 |  |  | 11-001 |  |
| 142223205 |  | Assembly of box 1 |  | 10d | 2010-10-25 | 2010-11-05 | 142223200a | 190d | 0d | VISTNG USERS [80 h]; PD UNIV STUDNT [40 h]; CONTRB UNIV LBR [400 h]; MECH TECH [80 h] | 5,357.6 | ELOUADRHIRI L | 1 | 1 |  | LATIFA E | 10-014 | 11-026 | 11 -035 | 13-002F |  |  | 12-007 | 12-054F |  |  |  |
| 142223210 |  | Stacking #1 |  | 46d | 2010-11-08 | 2011-01-21 | 142223205 | 190d | 0d | PD UNIV STUDNT [40 h]; VISTNG USERS [360 h]; MECH TECH [240 h]; PD UNIV STAFF [240 h]; CONTRB UNIV LBR [400 h] | 30,561.2 | ELOUADRHIRI L | 1 | 1 |  | LATIFA E | 10-014 | 11-026 | 11 -035 | 13-002F |  |  | 12-007 | 12-054F |  |  |  |
| 142223037 |  | EC-P-#2 Vend Fab of Wave Shifting Fibers (FWD CAL) |  | 175d | 2011-01-05 | 2011-09-13 | 142223012, 9-110M FS+60d | 508d |  | PROCUREMENT>$50K 69; SCIENTIST [20 h] | 126,090.63 | ELOUADRHIRI L | 1 | 1 |  | LATIFA E | 10-014 | 11-026 | 11 -035 | 13-002F | APP |  |  |  |  |  |  |
| 142223215 |  | Close Module 1 |  | 5d | 2011-01-24 | 2011-01-28 | 142223210 | 190d | 0d | MECH TECH [40 h]; VISTNG USERS [40 h]; PD UNIV STUDNT [40 h]; CONTRB UNIV LBR [40 h] | 2,885.6 | ELOUADRHIRI L | 1 | 1 |  | LATIFA E | 10-014 | 11-026 | 11 -035 | 13-002F |  |  | 12-007 | 12-054F |  |  |  |
| 142223220 |  | Prepare Components Module 2 |  | 10d | 2011-01-31 | 2011-02-11 | 142223215 | 190d | 0d | SUPPLIES & MATERIALS; CONTRB UNIV LBR [80 h]; PD UNIV STUDNT [40 h]; MECH TECH [80 h]; VISTNG USERS [80 h] | 10,517.1 | ELOUADRHIRI L | 1 | 1 |  | LATIFA E | 10-014 | 11-026 | 11 -035 | 13-002F |  |  | 12-007 | 12-054F |  |  |  |
| 142223325 |  | Setup module1 |  | 6d | 2011-01-31 | 2011-02-07 | 142223215, 142223320 | 206d | 0d | CONTRB UNIV LBR [40 h]; MECH TECH [24 h]; VISTNG USERS [48 h]; PD UNIV STUDNT [40 h] | 2,346.32 | ELOUADRHIRI L | 1 | 1 |  | LATIFA E | 10-014 | 11-026 | 11 -035 | 13-002F |  |  | 12-007 |  |  |  |  |
| 142223330 |  | Prepare components |  | 11d | 2011-02-08 | 2011-02-23 | 142223317a, 142223325 | 206d | 0d | PD UNIV STUDNT [40 h]; MECH TECH [44 h]; VISTNG USERS [88 h]; CONTRB UNIV LBR [40 h] | 3,956.92 | ELOUADRHIRI L | 1 | 1 |  | LATIFA E | 10-014 | 11-026 | 11 -035 | 13-002F |  |  | 12-007 |  |  |  |  |
| 142223225 |  | Assembly of box 2 |  | 10d | 2011-02-14 | 2011-02-28 | 142223220 | 190d | 0d | PD UNIV STUDNT [80 h]; VISTNG USERS [80 h]; MECH TECH [80 h]; CONTRB UNIV LBR [40 h] | 5,771.2 | ELOUADRHIRI L | 1 | 1 |  | LATIFA E | 10-014 | 11-026 | 11 -035 | 13-002F |  |  | 12-007 | 12-054F |  |  |  |
| 142223335 |  | Fiber/PMT assembly Module #1 |  | 31d | 2011-02-24 | 2011-04-07 | 142223330, 142223318 FS-40d, 142223316 FS-285d | 206d | 0d | CONTRB UNIV LBR [120 h]; VISTNG USERS [248 h]; PD UNIV STUDNT [120 h]; PD UNIV STAFF [248 h] | 19,389.44 | ELOUADRHIRI L | 1 | 1 |  | LATIFA E | 10-014 | 11-026 | 11 -035 | 13-002F |  |  | 12-007 |  |  |  |  |
| 142223230 |  | Stacking #2 |  | 46d | 2011-03-01 | 2011-05-03 | 142223225 | 190d | 0d | CONTRB UNIV LBR [80 h]; PD UNIV STUDNT [200 h]; VISTNG USERS [360 h]; MECH TECH [240 h]; PD UNIV STAFF [240 h] | 32,215.6 | ELOUADRHIRI L | 1 | 1 |  | LATIFA E | 10-014 | 11-026 | 11 -035 | 13-002F |  |  | 12-007 | 12-054F |  |  |  |
| 142223340 |  | Prepare #1 for test |  | 11d | 2011-04-08 | 2011-04-22 | 142223335, 142223337 FS-196d | 206d | 0d | PD UNIV STUDNT [40 h]; VISTNG USERS [88 h]; CONTRB UNIV LBR [40 h] | 2,061.84 | ELOUADRHIRI L | 1 | 1 |  | LATIFA E | 10-014 | 11-026 | 11 -035 | 13-002F |  |  | 12-007 |  |  |  |  |
| 142223345 |  | Testing #1 |  | 11d | 2011-04-25 | 2011-05-09 | 142223340 | 206d | 0d | CONTRB UNIV LBR [88 h]; PD UNIV STAFF [88 h]; VISTNG USERS [88 h] | 6,439.84 | ELOUADRHIRI L | 1 | 1 |  | LATIFA E | 10-014 | 11-026 | 11 -035 | 13-002F |  |  | 12-007 |  |  |  |  |
| 142223235 |  | Close Module 2 |  | 6d | 2011-05-04 | 2011-05-11 | 142223230, 142223232 FS-163d | 190d | 0d | PD UNIV STUDNT [40 h]; VISTNG USERS [48 h]; MECH TECH [48 h]; CONTRB UNIV LBR [40 h] | 3,380 | ELOUADRHIRI L | 1 | 1 |  | LATIFA E | 10-014 | 11-026 | 11 -035 | 13-002F |  |  | 12-007 | 12-054F |  |  |  |
| 142223535 |  | Prepare the storage area |  | 12d | 2011-05-04 | 2011-05-19 | 142223350 FS-10d | 571d | 0d |  |  | ELOUADRHIRI L | 1 | 1 |  | LATIFA E | 10-014 | 11-026 | 11 -035 | 13-002F |  |  |  |  |  |  |  |
| 142223350 |  | Disassemble #1 |  | 6d | 2011-05-10 | 2011-05-17 | 142223345 | 206d | 0d | PD UNIV STUDNT [40 h]; VISTNG USERS [48 h]; CONTRB UNIV LBR [40 h] | 1,312.64 | ELOUADRHIRI L | 1 | 1 |  | LATIFA E | 10-014 | 11-026 | 11 -035 | 13-002F |  |  | 12-007 |  |  |  |  |
| 142223355 |  | Move #1 to storage |  | 2d | 2011-05-18 | 2011-05-19 | 142223350 | 206d | 0d | MECH TECH [16 h] | 689.12 | ELOUADRHIRI L | 1 | 1 |  | LATIFA E | 10-014 | 11-026 | 11 -035 | 13-002F |  |  | 12-007 |  |  |  |  |
| 142223240 |  | Prepare Components Module 3 |  | 10d | 2011-05-19 | 2011-06-02 | 142223235 FS+5d | 190d | 0d | SUPPLIES & MATERIALS; PD UNIV STUDNT [40 h]; CONTRB UNIV LBR [60 h]; VISTNG USERS [80 h]; MECH TECH [80 h] | 10,517.1 | ELOUADRHIRI L | 1 | 1 |  | LATIFA E | 10-014 | 11-026 | 11 -035 | 13-002F |  |  | 12-007 | 12-054F |  |  |  |
| 142223360 |  | Setup module2 |  | 6d | 2011-05-20 | 2011-05-27 | 142223235, 142223355 | 206d | 0d | VISTNG USERS [48 h]; CONTRB UNIV LBR [40 h]; MECH TECH [24 h]; PD UNIV STUDNT [40 h] | 2,346.32 | ELOUADRHIRI L | 1 | 1 |  | LATIFA E | 10-014 | 11-026 | 11 -035 | 13-002F |  |  | 12-007 |  |  |  |  |
| 142223540 |  | Store module #1 |  | 1d | 2011-05-20 | 2011-05-20 | 142223535, 142223355 | 571d | 77d |  |  | ELOUADRHIRI L | 1 | 1 |  | LATIFA E | 10-014 | 11-026 | 11 -035 | 13-002F |  |  |  |  |  |  |  |
| 142223365 |  | Prepare components |  | 11d | 2011-05-31 | 2011-06-14 | 142223360 | 206d | 0d | MECH TECH [44 h]; PD UNIV STUDNT [40 h]; VISTNG USERS [88 h]; CONTRB UNIV LBR [40 h] | 3,956.92 | ELOUADRHIRI L | 1 | 1 |  | LATIFA E | 10-014 | 11-026 | 11 -035 | 13-002F |  |  | 12-007 |  |  |  |  |
| 142223245 |  | Assembly of box 3 |  | 10d | 2011-06-03 | 2011-06-16 | 142223240 | 190d | 0d | PD UNIV STUDNT [40 h]; VISTNG USERS [80 h]; MECH TECH [80 h]; CONTRB UNIV LBR [40 h] | 5,357.6 | ELOUADRHIRI L | 1 | 1 |  | LATIFA E | 10-014 | 11-026 | 11 -035 | 13-002F |  |  | 12-007 | 12-054F |  |  |  |
| 142223370 |  | Fiber/PMT assembly Module #2 |  | 31d | 2011-06-15 | 2011-07-28 | 142223365 | 206d | 0d | VISTNG USERS [248 h]; PD UNIV STUDNT [120 h]; PD UNIV STAFF [248 h]; CONTRB UNIV LBR [120 h] | 19,389.44 | ELOUADRHIRI L | 1 | 1 |  | LATIFA E | 10-014 | 11-026 | 11 -035 | 13-002F |  |  | 12-007 |  |  |  |  |
| 142223250 |  | Stacking #3 |  | 46d | 2011-06-17 | 2011-08-22 | 142223245 | 190d | 0d | MECH TECH [240 h]; PD UNIV STAFF [240 h]; CONTRB UNIV LBR [80 h]; PD UNIV STUDNT [160 h]; VISTNG USERS [360 h] | 31,802 | ELOUADRHIRI L | 1 | 1 |  | LATIFA E | 10-014 | 11-026 | 11 -035 | 13-002F |  |  | 12-007 | 12-054F |  |  |  |
| 142223375 |  | Prepare #2 for test |  | 11d | 2011-07-29 | 2011-08-12 | 142223370, 142223372 FS-196d | 206d | 0d | PD UNIV STUDNT [40 h]; VISTNG USERS [88 h]; CONTRB UNIV LBR [80 h] | 2,061.84 | ELOUADRHIRI L | 1 | 1 |  | LATIFA E | 10-014 | 11-026 | 11 -035 | 13-002F |  |  | 12-007 |  |  |  |  |
| 142223380 |  | Testing #2 |  | 11d | 2011-08-15 | 2011-08-29 | 142223375 | 206d | 0d | VISTNG USERS [88 h]; PD UNIV STAFF [88 h]; CONTRB UNIV LBR [88 h] | 6,439.84 | ELOUADRHIRI L | 1 | 1 |  | LATIFA E | 10-014 | 11-026 | 11 -035 | 13-002F |  |  | 12-007 |  |  |  |  |
| 142223255 |  | Close Module 3 |  | 6d | 2011-08-23 | 2011-08-30 | 142223252 FS-163d, 142223250 | 190d | 0d | MECH TECH [48 h]; CONTRB UNIV LBR [40 h]; PD UNIV STUDNT [40 h]; VISTNG USERS [48 h] | 3,380 | ELOUADRHIRI L | 1 | 1 |  | LATIFA E | 10-014 | 11-026 | 11 -035 | 13-002F |  |  | 12-007 | 12-054F |  |  |  |
| 142223385 |  | Disassemble #2 |  | 6d | 2011-08-30 | 2011-09-07 | 142223380 | 206d | 0d | CONTRB UNIV LBR [40 h]; VISTNG USERS [48 h]; PD UNIV STUDNT [40 h] | 1,312.64 | ELOUADRHIRI L | 1 | 1 |  | LATIFA E | 10-014 | 11-026 | 11 -035 | 13-002F |  |  | 12-007 |  |  |  |  |
| 142223260 |  | Prepare Components Module 4 |  | 11d | 2011-09-08 | 2011-09-22 | 142223255 FS+5d | 190d | 0d | MECH TECH [88 h]; SUPPLIES & MATERIALS; CONTRB UNIV LBR [60 h]; PD UNIV STUDNT [40 h]; VISTNG USERS [88 h] | 11,011.5 | ELOUADRHIRI L | 1 | 1 |  | LATIFA E | 10-014 | 11-026 | 11 -035 | 13-002F |  |  |  | 12-054F |  |  |  |
| 142223390 |  | Move #2 to storage |  | 2d | 2011-09-08 | 2011-09-09 | 142223385 | 206d | 0d | MECH TECH [16 h] | 689.12 | ELOUADRHIRI L | 1 | 1 |  | LATIFA E | 10-014 | 11-026 | 11 -035 | 13-002F |  |  | 12-007 |  |  |  |  |
| 142223395 |  | Setup module3 |  | 6d | 2011-09-12 | 2011-09-19 | 142223255, 142223390 | 206d | 0d | MECH TECH [24 h]; CONTRB UNIV LBR [40 h]; VISTNG USERS [48 h]; PD UNIV STUDNT [40 h] | 2,346.32 | ELOUADRHIRI L | 1 | 1 |  | LATIFA E | 10-014 | 11-026 | 11 -035 | 13-002F |  |  | 12-007 |  |  |  |  |
| 142223545 |  | Store module #2 |  | 1d | 2011-09-12 | 2011-09-12 | 142223390, 142223540 | 494d | 273d |  |  | ELOUADRHIRI L | 1 | 1 |  | LATIFA E | 10-014 | 11-026 | 11 -035 | 13-002F |  |  |  |  |  |  |  |
| 142223400 |  | Prepare components FY11 |  | 9d | 2011-09-20 | 2011-09-30 | 142223395 | 206d | 0d | CONTRB UNIV LBR [32.73 h]; VISTNG USERS [72 h]; MECH TECH [36 h]; PD UNIV STUDNT [32.73 h] | 3,237.51 | ELOUADRHIRI L | 1 | 1 |  | LATIFA E | 10-014 | 11-026 | 11 -035 | 13-002F |  |  | 12-007 |  |  |  | 12-001 |
| 142223265 |  | Assembly of box 4 FY11 |  | 6d | 2011-09-23 | 2011-09-30 | 142223260 | 190d | 0d | PD UNIV STUDNT [21.82 h]; MECH TECH [48 h]; CONTRB UNIV LBR [21.82 h]; VISTNG USERS [48 h] | 3,192.02 | ELOUADRHIRI L | 1 | 1 |  | LATIFA E | 10-014 | 11-026 | 11 -035 | 13-002F |  |  |  | 12-054F |  |  | 12-001 |
| 142223265a |  | Assembly of box 4 FY12 |  | 5d | 2011-10-03 | 2011-10-07 | 142223265 | 190d | 0d | CONTRB UNIV LBR [18.18 h]; VISTNG USERS [40 h]; PD UNIV STUDNT [18.18 h]; MECH TECH [40 h] | 2,744.78 | ELOUADRHIRI L | 1 | 1 |  | LATIFA E | 10-014 | 11-026 | 11 -035 | 13-002F |  |  |  | 12-054F |  |  | 12-001 |
| 142223400a |  | Prepare components FY12 |  | 2d | 2011-10-03 | 2011-10-04 | 142223400 | 206d | 0d | CONTRB UNIV LBR [7.27 h]; VISTNG USERS [16 h]; MECH TECH [8 h]; PD UNIV STUDNT [7.27 h] | 742.37 | ELOUADRHIRI L | 1 | 1 |  | LATIFA E | 10-014 | 11-026 | 11 -035 | 13-002F |  |  | 12-007 |  |  |  | 12-001 |
| 142223405 |  | Fiber/PMT assembly Module #3 |  | 19d | 2011-10-05 | 2011-10-31 | 142223400a | 206d | 177d | PD UNIV STUDNT [73.55 h]; VISTNG USERS [152 h]; PD UNIV STAFF [152 h]; CONTRB UNIV LBR [73.55 h] | 12,263.89 | ELOUADRHIRI L | 1 | 1 |  | LATIFA E | 10-014 | 11-026 | 11 -035 | 13-002F |  |  | 12-007 |  |  |  |  |
| 142223270 |  | Stacking #4 |  | 16d | 2011-10-10 | 2011-10-31 | 142223265a | 190d | 170d | PD UNIV STAFF [83.48 h]; CONTRB UNIV LBR [27.83 h]; VISTNG USERS [125.22 h]; PD UNIV STUDNT [41.74 h]; MECH TECH [83.48 h] | 11,266.56 | ELOUADRHIRI L | 1 | 1 |  | LATIFA E | 10-014 | 11-026 | 11 -035 | 13-002F |  |  | 12-007 | 12-054F |  |  |  |
| 142223232 |  | ETC Revision of Stacking #2 |  | 37d | 2011-11-01 | 2011-12-30 | 9-120M FS+21d | 190d | 0d | VISTNG USERS [452 h]; PD UNIV STAFF [148 h] | 17,053.28 | ELOUADRHIRI L | 1 | 1 |  | LATIFA E | 10-014 | 11-026 | 11 -035 | 13-002F |  |  | 12-007 | 12-054F |  |  |  |

Notes:
- 142223535: Explanation: space required from the lab.

| ID | Activity | Type | Duration | Start | Finish | Predecessors | Total float | Free float | Calendar | Resources | Cost | RESP - Responsibility | STRT%COMP for CM EVM | FNSH%COMP for CM EVM | CAM RESPONSIBLE | CR 10-014 | CR 11-026 | CR 11-035 | CR 12-007 | CR 13-002 | CR 12-054 | CR 12-053 | CR 11-038 | CR 13-014 | ReBaseline Actuals Adjustment | Original Activity ID Rebaseline | Over Under Fixed | EVMS Reporting Codes | CR 13-010 | BOE Procurement | BOE Labor | CR 13-015 | Post Rebaseline | Obligated Prior to Rebaseline | CR 14-001 |
| --- | --- | --- | --- | --- | --- | --- | --- | --- | --- | --- | --- | --- | --- | --- | --- | --- | --- | --- | --- | --- | --- | --- | --- | --- | --- | --- | --- | --- | --- | --- | --- | --- | --- | --- | --- |
| 142223337 | ETC Revision of Fiber/PMT assembly Module #1 |  | 31d | 2011-12-02 | 2012-01-24 | 9-120M FS+42d | 206d | 0d |  | VISTNG USERS [372 h]; PD UNIV STAFF [124 h] | 14,158.32 | ELOUADRHIRI L | 1 | 1 | LATIFA E | 10-014 | 11-026 | 11 -035 | 12-007 | 13-002F |  |  |  |  |  |  |  |  |  |  |  |  |  |  |  |
| 142223319 | WLS Fibers final set procurement |  | 81d | 2012-01-05 | 2012-04-30 | 9-120M FS+60d | 354d |  |  | PROCUREMENT>$50K 69; PROCUREMENT<$50K 60 | 58,000 | ELOUADRHIRI L | 1 | 1 | LATIFA E |  |  |  | 12-007 | 13-002F |  |  |  |  |  |  |  |  |  |  |  |  |  |  |  |
| 142223252 | ETC Revision of Stacking #3 |  | 46d | 2012-01-09 | 2012-03-14 | 9-120M FS+62d | 217d | 27d |  | PD UNIV STAFF [148 h]; VISTNG USERS [452 h] | 17,053.28 | ELOUADRHIRI L | 1 | 1 | LATIFA E | 10-014 | 11-026 | 11 -035 | 12-007 | 13-002F | 12-054F |  |  |  |  |  |  |  |  |  |  |  |  |  |  |
| 142223280 | Prepare Components Module 5 |  | 11d | 2012-01-09 | 2012-01-24 | 142223275 FS-165d | 20d | 0d |  | VISTNG USERS [88 h]; MECH TECH [88 h]; PD UNIV STUDNT [40 h]; SUPPLIES & MATERIALS; CONTRB UNIV LBR [60 h] | 11,362.65 | ELOUADRHIRI L | 1 | 1 | LATIFA E | 10-014 | 11-026 | 11 -035 | 12-007 | 13-002F | 12-054F |  |  |  |  |  |  |  |  |  |  |  |  |  |  |
| 142223372 | ETC Revision of Fiber/PMT assembly Module #2 |  | 31d | 2012-04-02 | 2012-05-14 | 9-120M FS+120d | 206d | 0d |  | PD UNIV STAFF [44 h]; VISTNG USERS [372 h] | 9,663.12 | ELOUADRHIRI L | 1 | 1 | LATIFA E | 10-014 | 11-026 | 11 -035 | 12-007 | 13-002F |  |  |  |  |  |  |  |  |  |  |  |  |  |  |  |
| 142223300 | Prepare Components Module 6 |  | 11d | 2012-04-24 | 2012-05-08 | 142223295 FS-210d | 64d | 29d |  | CONTRB UNIV LBR [60 h]; VISTNG USERS [88 h]; MECH TECH [88 h]; PD UNIV STUDNT [40 h]; SUPPLIES & MATERIALS | 11,362.65 | ELOUADRHIRI L | 1 | 1 | LATIFA E | 10-014 | 11-026 | 11 -035 | 12-007 | 13-002F |  |  |  |  |  |  |  |  |  |  |  |  |  |  |  |
| 142223565 | Procurement of PMT's and Dividers |  | 130d | 2012-05-01 | 2012-11-01 | 9-120M FS+141d | 189d | 0d |  | PROCUREMENT<$50K 60 NO ESCALATION FY13; PROCUREMENT>$50K 69 NO ESCALATION FY13 | 79,328.91 | ELOUADRHIRI L | 1 | 1 | LATIFA E | 10-014 | 11-026 | 11 -035 |  | 13-002F |  |  |  |  |  |  |  |  |  |  |  |  |  |  |  |
| 142223272 | Stacking #4 Revised |  | 30d | 2012-07-12 | 2012-08-22 | 9-120M FS+191d, 142223270 | 20d | 0d |  | PD UNIV STAFF [304.4 h]; CONTRB UNIV LBR [52.17 h]; VISTNG USERS [686.8 h]; PD UNIV STUDNT [78.26 h]; MECH TECH [156.52 h] | 38,170.86 | ELOUADRHIRI L | 1 | 1 | LATIFA E | 10-014 | 11-026 | 11 -035 | 12-007 | 13-002F | 12-054F |  |  |  |  |  |  |  |  |  |  |  |  |  |  |
| 142223407 | Fiber/PMT assembly Revised Module #3 |  | 31d | 2012-07-23 | 2012-09-04 | 142223405, 9-120M FS+198d | 29d | 0d |  | PD UNIV STUDNT [46.45 h]; VISTNG USERS [468 h]; PD UNIV STAFF [140 h]; CONTRB UNIV LBR [46.45 h] | 17,408.66 | ELOUADRHIRI L | 1 | 1 | LATIFA E | 10-014 | 11-026 | 11 -035 | 12-007 | 13-002F |  |  |  |  |  |  |  |  |  |  |  |  |  |  |  |
| 142223275 | Close Module 4 |  | 6d | 2012-08-23 | 2012-08-30 | 142223272, 142223270 | 20d | 0d |  | PD UNIV STUDNT [40 h]; CONTRB UNIV LBR [40 h]; VISTNG USERS [48 h]; MECH TECH [48 h] | 3,487.76 | ELOUADRHIRI L | 1 | 1 | LATIFA E | 10-014 | 11-026 | 11 -035 | 12-007 | 13-002F | 12-054F |  |  |  |  |  |  |  |  |  |  |  |  |  |  |
| 142223410 | Prepare #3 for test |  | 11d | 2012-09-05 | 2012-09-19 | 142223407, 142223405 | 29d | 0d |  | CONTRB UNIV LBR [40 h]; VISTNG USERS [88 h]; PD UNIV STUDNT [40 h] | 2,127.84 | ELOUADRHIRI L | 1 | 1 | LATIFA E | 10-014 | 11-026 | 11 -035 | 12-007 | 13-002F |  |  |  |  |  |  |  |  |  |  |  |  |  |  |  |
| 142223415 | Testing #3 FY12 |  | 7d | 2012-09-20 | 2012-09-28 | 142223410 | 29d | 0d |  | PD UNIV STAFF [56 h]; VISTNG USERS [56 h]; CONTRB UNIV LBR [56 h] | 4,229.12 | ELOUADRHIRI L | 1 | 1 | LATIFA E | 10-014 | 11-026 | 11 -035 | 12-007 | 13-002F |  | 12-053 |  |  |  |  |  |  |  |  |  |  |  |  |  |
| 142223285 | Assembly of box 5 FY12 |  | 4d | 2012-09-25 | 2012-09-28 | 142223280 FS+170d | 20d | 0d |  | CONTRB UNIV LBR [14.55 h]; VISTNG USERS [32 h]; MECH TECH [32 h]; PD UNIV STUDNT [14.55 h] | 2,195.89 | ELOUADRHIRI L | 1 | 1 | LATIFA E | 10-014 | 11-026 | 11 -035 | 12-007 | 13-002F | 12-054F | 12-053 |  |  |  |  |  |  |  |  |  |  |  |  |  |
| 142223285a | Assembly of box 5 FY13 |  | 7d | 2012-10-01 | 2012-10-09 | 142223285 | 20d | 0d |  | CONTRB UNIV LBR [25.45 h]; VISTNG USERS [56 h]; MECH TECH [56 h]; PD UNIV STUDNT [25.45 h] | 3,965.56 | ELOUADRHIRI L | 1 | 1 | LATIFA E | 10-014 | 11-026 | 11 -035 | 12-007 | 13-002F | 12-054F | 12-053 |  |  |  |  |  |  |  |  |  |  |  |  |  |
| 142223415a | Testing #3 FY13 |  | 4d | 2012-10-01 | 2012-10-04 | 142223415 | 29d | 0d |  | PD UNIV STAFF [32 h]; VISTNG USERS [32 h]; CONTRB UNIV LBR [32 h] | 2,493.76 | ELOUADRHIRI L | 1 | 1 | LATIFA E | 10-014 | 11-026 | 11 -035 | 12-007 | 13-002F |  | 12-053 |  |  |  |  |  |  |  |  |  |  |  |  |  |
| 142223420 | Disassemble #3 |  | 6d | 2012-10-05 | 2012-10-12 | 142223415a | 29d | 0d |  | CONTRB UNIV LBR [40 h]; PD UNIV STUDNT [40 h]; VISTNG USERS [48 h] | 1,398 | ELOUADRHIRI L | 1 | 1 | LATIFA E | 10-014 | 11-026 | 11 -035 | 12-007 | 13-002F |  |  |  |  |  |  |  |  |  |  |  |  |  |  |  |
| 142223425 | Move #3 to storage |  | 2d | 2012-10-15 | 2012-10-16 | 142223420 | 29d | 0d |  | MECH TECH [16 h] | 733.76 | ELOUADRHIRI L | 1 | 1 | LATIFA E | 10-014 | 11-026 | 11 -035 | 12-007 | 13-002F |  |  |  |  |  |  |  |  |  |  |  |  |  |  |  |
| 142223430 | Setup module 4 |  | 6d | 2012-10-17 | 2012-10-24 | 142223275, 142223425 | 29d | 0d |  | CONTRB UNIV LBR [40 h]; MECH TECH [24 h]; PD UNIV STUDNT [40 h]; VISTNG USERS [48 h] | 2,498.64 | ELOUADRHIRI L | 1 | 1 | LATIFA E | 10-014 | 11-026 | 11 -035 | 12-007 | 13-002F |  |  |  |  |  |  |  |  |  |  |  |  |  |  |  |
| 142223550 | Store module #3 |  | 1d | 2012-10-17 | 2012-10-17 | 142223545, 142223425 | 221d | 77d |  |  |  | ELOUADRHIRI L | 1 | 1 | LATIFA E | 10-014 | 11-026 | 11 -035 | 12-007 | 13-002F |  |  |  |  |  |  |  |  |  |  |  |  |  |  |  |
| 142223435 | Prepare components |  | 11d | 2012-10-25 | 2012-11-08 | 142223430 | 29d | 0d |  | VISTNG USERS [88 h]; MECH TECH [44 h]; CONTRB UNIV LBR [40 h]; PD UNIV STUDNT [40 h] | 4,213.84 | ELOUADRHIRI L | 1 | 1 | LATIFA E | 10-014 | 11-026 | 11 -035 | 12-007 | 13-002F |  |  |  |  |  |  |  |  |  |  |  |  |  |  |  |
| 142223570 | Repair Calorimeter PMT's |  | 35d | 2012-11-02 | 2012-12-31 | 142223565 | 189d |  |  | MECH TECH [480 h]; PD UNIV STAFF [120 h]; VISTNG USERS [160 h] | 32,162.4 | ELOUADRHIRI L | 1 | 1 | LATIFA E | 10-014 | 11-026 | 11 -035 | 12-007 | 13-002F |  |  | 11-038 |  |  |  |  |  |  |  |  |  |  |  |  |
| 142223440 | Fiber/PMT assembly Module #4 |  | 31d | 2012-11-09 | 2013-01-02 | 142223435 | 29d | 0d |  | VISTNG USERS [620 h]; PD UNIV STUDNT [120 h]; PD UNIV STAFF [292 h]; CONTRB UNIV LBR [120 h] | 30,620.36 | ELOUADRHIRI L | 1 | 1 | LATIFA E | 10-014 | 11-026 | 11 -035 | 12-007 | 13-002F |  |  |  |  |  |  |  |  |  |  |  |  |  |  |  |
| 142223290 | Stacking #5 |  | 46d | 2012-12-07 | 2013-02-20 | 142223285a FS+40d | 20d | 0d |  | PD UNIV STAFF [388 h]; CONTRB UNIV LBR [80 h]; VISTNG USERS [812 h]; MECH TECH [240 h]; PD UNIV STUDNT [120 h] | 51,023.24 | ELOUADRHIRI L | 1 | 1 | LATIFA E | 10-014 | 11-026 | 11 -035 | 12-007 | 13-002F | 12-054 |  |  |  |  |  |  |  |  |  |  |  |  |  |  |
| 142223445 | Prepare #4 for test |  | 11d | 2013-01-03 | 2013-01-17 | 142223440 | 29d | 0d |  | PD UNIV STUDNT [40 h]; VISTNG USERS [88 h]; CONTRB UNIV LBR [40 h] | 2,196 | ELOUADRHIRI L | 1 | 1 | LATIFA E | 10-014 | 11-026 | 11 -035 | 12-007 | 13-002F |  |  |  |  |  |  |  |  |  |  |  |  |  |  |  |
| 142223450 | Testing #4 |  | 11d | 2013-01-18 | 2013-02-04 | 142223445 | 29d | 0d |  | CONTRB UNIV LBR [88 h]; PD UNIV STAFF [88 h]; VISTNG USERS [88 h] | 6,857.84 | ELOUADRHIRI L | 1 | 1 | LATIFA E | 10-014 | 11-026 | 11 -035 | 12-007 | 13-002F |  |  |  |  |  |  |  |  |  |  |  |  |  |  |  |
| 142223455 | Disassemble #4 |  | 6d | 2013-02-05 | 2013-02-12 | 142223450 | 29d | 0d |  | CONTRB UNIV LBR [40 h]; VISTNG USERS [48 h]; PD UNIV STUDNT [40 h] | 1,398 | ELOUADRHIRI L | 1 | 1 | LATIFA E | 10-014 | 11-026 | 11 -035 | 12-007 | 13-002F |  |  |  |  |  |  |  |  |  |  |  |  |  |  |  |
| 142223460 | Move #4 to storage |  | 2d | 2013-02-13 | 2013-02-14 | 142223455 | 29d | 0d |  | MECH TECH [16 h] | 733.76 | ELOUADRHIRI L | 1 | 1 | LATIFA E | 10-014 | 11-026 | 11 -035 | 12-007 | 13-002F |  |  |  |  |  |  |  |  |  |  |  |  |  |  |  |
| 142223555 | Store module #4 |  | 1d | 2013-02-15 | 2013-02-15 | 142223460, 142223550 | 144d | 86d |  |  |  | ELOUADRHIRI L | 1 | 1 | LATIFA E | 10-014 | 11-026 | 11 -035 | 12-007 | 13-002F |  |  |  |  |  |  |  |  |  |  |  |  |  |  |  |
| 142223295 | Close Module 5 |  | 6d | 2013-02-21 | 2013-02-28 | 142223290 | 20d | 0d |  | PD UNIV STUDNT [40 h]; CONTRB UNIV LBR [40 h]; VISTNG USERS [48 h]; MECH TECH [48 h] | 3,599.28 | ELOUADRHIRI L | 1 | 1 | LATIFA E | 10-014 | 11-026 | 11 -035 | 12-007 | 13-002F | 12-054 |  |  |  |  |  |  |  |  |  |  |  |  |  |  |
| 142223305 | Assembly of box 6 |  | 11d | 2013-03-01 | 2013-03-15 | 142223295, 142223300 FS+170d | 35d | 0d |  | VISTNG USERS [88 h]; MECH TECH [88 h]; PD UNIV STUDNT [40 h]; CONTRB UNIV LBR [40 h] | 6,231.68 | ELOUADRHIRI L | 1 | 1 | LATIFA E | 10-014 | 11-026 | 11 -035 | 12-007 | 13-002F | 12-054 |  |  |  |  |  |  |  |  |  |  |  |  |  |  |
| 142223465 | Setup module5 |  | 6d | 2013-03-01 | 2013-03-08 | 142223460, 142223295 | 20d | 0d |  | MECH TECH [24 h]; VISTNG USERS [48 h]; PD UNIV STUDNT [40 h]; CONTRB UNIV LBR [40 h] | 2,498.64 | ELOUADRHIRI L | 1 | 1 | LATIFA E | 10-014 | 11-026 | 11 -035 | 12-007 | 13-002F | 12-054 |  |  |  |  |  |  |  |  |  |  |  |  |  |  |
| 142223470 | Prepare components |  | 11d | 2013-03-11 | 2013-03-25 | 142223465 | 20d | 0d |  | CONTRB UNIV LBR [38 h]; MECH TECH [44 h]; PD UNIV STUDNT [40 h]; VISTNG USERS [88 h] | 4,213.84 | ELOUADRHIRI L | 1 | 1 | LATIFA E | 10-014 | 11-026 | 11 -035 | 12-007 | 13-002F | 12-054 |  |  |  |  |  |  |  |  |  |  |  |  |  |  |
| 142223310 | Stacking #6 |  | 46d | 2013-03-18 | 2013-05-20 | 142223305 | 35d | 0d |  | VISTNG USERS [812 h]; CONTRB UNIV LBR [80 h]; MECH TECH [240 h]; PD UNIV STUDNT [88 h]; PD UNIV STAFF [388 h] | 50,670.92 | ELOUADRHIRI L | 1 | 1 | LATIFA E | 10-014 | 11-026 | 11 -035 | 12-007 | 13-002F | 12-054 |  |  |  |  |  |  |  |  |  |  |  |  |  |  |
| 142223475 | Fiber/PMT assembly Module #5 |  | 31d | 2013-03-26 | 2013-05-07 | 142223470 | 20d | 0d |  | PD UNIV STUDNT [120 h]; VISTNG USERS [620 h]; PD UNIV STAFF [292 h]; CONTRB UNIV LBR [120 h] | 30,620.36 | ELOUADRHIRI L | 1 | 1 | LATIFA E | 10-014 | 11-026 | 11 -035 | 12-007 | 13-002F | 12-054 |  |  |  |  |  |  |  |  |  |  |  |  |  |  |
| 142223480 | Prepare #5 for test |  | 11d | 2013-05-08 | 2013-05-22 | 142223475 | 20d | 0d |  | PD UNIV STUDNT [40 h]; CONTRB UNIV LBR [40 h]; VISTNG USERS [88 h] | 2,196 | ELOUADRHIRI L | 1 | 1 | LATIFA E | 10-014 | 11-026 | 11 -035 | 12-007 | 13-002F | 12-054 |  |  |  |  |  |  |  |  |  |  |  |  |  |  |
| 142223315 | Close Module 6 |  | 6d | 2013-05-21 | 2013-05-29 | 142223310 | 35d | 15d |  | VISTNG USERS [48 h]; MECH TECH [48 h]; PD UNIV STUDNT [40 h]; CONTRB UNIV LBR [33.6 h] | 3,599.28 | ELOUADRHIRI L | 1 | 1 | LATIFA E | 10-014 | 11-026 | 11 -035 | 12-007 | 13-002F | 12-054 |  |  |  |  |  |  |  |  |  |  |  |  |  |  |
| 142223485 | Testing #5 |  | 11d | 2013-05-23 | 2013-06-07 | 142223480 | 20d | 0d |  | CONTRB UNIV LBR [88 h]; PD UNIV STAFF [88 h]; VISTNG USERS [88 h] | 6,857.84 | ELOUADRHIRI L | 1 | 1 | LATIFA E | 10-014 | 11-026 | 11 -035 | 12-007 | 13-002F | 12-054 |  |  |  |  |  |  |  |  |  |  |  |  |  |  |
| 142223490 | Disassemble #5 |  | 6d | 2013-06-10 | 2013-06-17 | 142223485 | 20d | 0d |  | PD UNIV STUDNT [40 h]; VISTNG USERS [48 h]; CONTRB UNIV LBR [40 h] | 1,398 | ELOUADRHIRI L | 1 | 1 | LATIFA E | 10-014 | 11-026 | 11 -035 | 12-007 | 13-002F | 12-054 |  |  |  |  |  |  |  |  |  |  |  |  |  |  |
| 142223495 | Move #5 to storage |  | 2d | 2013-06-18 | 2013-06-19 | 142223490 | 20d | 0d |  | MECH TECH [16 h] | 733.76 | ELOUADRHIRI L | 1 | 1 | LATIFA E | 10-014 | 11-026 | 11 -035 | 12-007 | 13-002F | 12-054 |  |  |  |  |  |  |  |  |  |  |  |  |  |  |
| 142223500 | Setup module 6 |  | 6d | 2013-06-20 | 2013-06-27 | 142223495, 142223315 | 20d | 0d |  | PD UNIV STUDNT [40 h]; MECH TECH [24 h]; CONTRB UNIV LBR [40 h]; VISTNG USERS [48 h] | 2,498.64 | ELOUADRHIRI L | 1 | 1 | LATIFA E | 10-014 | 11-026 | 11 -035 | 12-007 | 13-002F | 12-054 |  |  |  |  |  |  |  |  |  |  |  |  |  |  |
| 142223560 | Store module #5 |  | 1d | 2013-06-20 | 2013-06-20 | 142223495, 142223555 | 58d | 0d |  |  |  | ELOUADRHIRI L | 1 | 1 | LATIFA E | 10-014 | 11-026 | 11 -035 | 12-007 | 13-002F | 12-054 |  |  |  |  |  |  |  |  |  |  |  |  |  |  |
| 142223505 | Prepare components |  | 11d | 2013-06-28 | 2013-07-15 | 142223500 | 20d | 0d |  | VISTNG USERS [88 h]; PD UNIV STUDNT [40 h]; MECH TECH [44 h]; CONTRB UNIV LBR [40 h] | 4,213.84 | ELOUADRHIRI L | 1 | 1 | LATIFA E | 10-014 | 11-026 | 11 -035 | 12-007 | 13-002F | 12-054 |  |  |  |  |  |  |  |  |  |  |  |  |  |  |
| 142223510 | Fiber/PMT assembly Module #6 |  | 31d | 2013-07-16 | 2013-08-27 | 142223505 | 20d | 0d |  | VISTNG USERS [620 h]; PD UNIV STUDNT [120 h]; PD UNIV STAFF [292 h]; CONTRB UNIV LBR [120 h] | 30,620.36 | ELOUADRHIRI L | 1 | 1 | LATIFA E | 10-014 | 11-026 | 11 -035 | 12-007 | 13-002F | 12-054 |  |  |  |  |  |  |  |  |  |  |  |  |  |  |
| 142223515 | Prepare #6 for test |  | 3d | 2013-08-28 | 2013-08-30 | 142223510 | 20d |  |  | PD UNIV STUDNT [10.91 h]; VISTNG USERS [24 h]; CONTRB UNIV LBR [10.91 h] | 598.93 | ELOUADRHIRI L | 1 | 1 | LATIFA E | 10-014 | 11-026 | 11 -035 | 12-007 | 13-002F | 12-054 |  |  | 13-014 |  |  |  |  |  |  |  |  |  |  |  |
| 142223530 | Move #6 to storage (Future Activity Complete prior to Rebaseline) |  | 1d | 2013-08-30 | 2013-08-30 | 9-130M FS+227d | 20d |  |  | MECH TECH |  | ELOUADRHIRI L | 1 | 1 | LATIFA E | 10-014 | 11-026 | 11 -035 | 12-007 | 13-002F | 12-054 |  |  | 13-014 |  |  |  |  |  |  |  |  |  |  |  |
| 142223575 | Re-Baseline Actuals Adjustment |  | 1d | 2013-08-30 | 2013-08-30 | 9-130M FS+227d | 20d |  |  | PROCUREMENT>$50K 69 NO ESCALATION | 128,199.08 | ELOUADRHIRI L | 1 | 1 | LATIFA E |  |  |  |  |  |  |  |  | 13-014 | ADJ |  |  |  |  |  |  |  |  |  |  |
| 242223312 | Procured Labor for Modules 5 & 6 |  | 39d | 2013-09-03 | 2013-10-25 | 9-130M FS+228d | 447d | 0d | 8/5 M-F w/JLAB Holidays ReBaseline | PROCUREMENT<$50K 60 NO ESCALATION FY14 | 4,374.99 | ELOUADRHIRI L | 1 | 1 | LATIFA E | 10-014 | 11-026 | 11 -035 | 12-007 | 13-002F | 12-054 |  |  |  |  | 242223312 | y | U | 13-010 | OB | PE | 13-015 | PR | OB |  |
| 242223520 | Testing #6 FY13 |  | 20d | 2013-09-03 | 2013-09-30 | 9-130M FS+228d | 447d | 0d | 8/5 M-F w/JLAB Holidays ReBaseline | PD UNIV STAFF [106.67 h]; VISTNG USERS [26.67 h]; CONTRB UNIV LBR [29.33 h] | 6,716.67 | ELOUADRHIRI L | 1 | 1 | LATIFA E | 10-014 | 11-026 | 11 -035 | 12-007 | 13-002F | 12-054 |  |  |  |  | 242223520 |  | U | 13-010 |  | PE | 13-015 | PR |  |  |
| 242223575 | Forklift Rental for ESB |  | 43d | 2013-09-03 | 2013-10-31 | 9-130M FS+228d | 528d | 525d | 8/5 M-F w/JLAB Holidays ReBaseline | PROCUREMENT<$50K 60 NO ESCALATION FY14 | 816.67 | ELOUADRHIRI L | 1 | 1 | LATIFA E | 10-014 | 11-026 | 11 -035 | 12-007 | 13-002F |  |  | 11-038 |  |  | 242223575 | y | U | 13-010 | OB |  | 13-015 | PR | OB |  |
| 242223520a | Testing #6 FY14 |  | 10d | 2013-10-01 | 2013-10-14 | 242223520, 9-130M FS+228d | 447d | 0d | 8/5 M-F w/JLAB Holidays ReBaseline | PD UNIV STAFF [53.33 h]; VISTNG USERS [13.33 h]; CONTRB UNIV LBR [14.67 h] | 3,465.32 | ELOUADRHIRI L | 1 | 1 | LATIFA E | 10-014 | 11-026 | 11 -035 | 12-007 | 13-002F | 12-054 |  |  |  |  | 242223520 |  | U | 13-010 |  | PE | 13-015 | PR |  | 14-001 |
| 242223525 | Disassemble #6 |  | 6d | 2013-10-15 | 2013-10-22 | 242223520a, 242223520 | 447d | 0d | 8/5 M-F w/JLAB Holidays ReBaseline | CONTRB UNIV LBR [40 h]; VISTNG USERS [80 h] | 1,647.2 | ELOUADRHIRI L | 1 | 1 | LATIFA E | 10-014 | 11-026 | 11 -035 | 12-007 | 13-002F | 12-054 |  |  |  |  | 242223525 |  | H | 13-010 |  | PE | 13-015 | PR |  | 14-001 |
| 242223530 | Move #6 to storage |  | 2d | 2013-10-23 | 2013-10-24 | 242223525 | 447d | 0d | 8/5 M-F w/JLAB Holidays ReBaseline | MECH TECH [40 h] | 1,892.8 | ELOUADRHIRI L | 1 | 1 | LATIFA E | 10-014 | 11-026 | 11 -035 | 12-007 | 13-002F | 12-054 |  |  |  |  | 242223530 |  | H |  |  | PE | 13-015 | PR |  | 14-001 |
| 242223562 | Store module #6 |  | 1d | 2013-10-25 | 2013-10-25 | 242223530 | 447d | 0d | 8/5 M-F w/JLAB Holidays ReBaseline |  |  | ELOUADRHIRI L | 1 | 1 | LATIFA E | 10-014 | 11-026 | 11 -035 | 12-007 | 13-002F | 12-054 |  |  |  |  | 242223562 |  | Z |  |  |  | 13-015 | PR |  |  |
| 242223563M | PCAL Complete | milestone | 0d | 2013-10-25 | 2013-10-25 | 242223312, 242223562 | 447d | 62d | 8/5 M-F w/JLAB Holidays ReBaseline |  |  | ELOUADRHIRI L | 1 | 1 | LATIFA E | 10-014 | 11-026 | 11 -035 | 12-007 | 13-002F | 12-054 |  |  |  |  | 242223563M |  | M |  |  |  | 13-015 | PR |  |  |
| 242223570 | Repair Calorimeter PMT's |  | 172d | 2014-03-05 | 2014-11-04 | 9-140M FS+100d | 279d | 276d | 8/5 M-F w/JLAB Holidays ReBaseline | PROCUREMENT<$50K 60 NO ESCALATION FY15 | 10,319 | ELOUADRHIRI L | 1 | 1 | LATIFA E | 10-014 | 11-026 | 11 -035 | 12-007 | 13-002F |  |  | 11-038 |  |  | 242223570 |  | U | 13-010 | PE |  | 13-015 | PR |  | 14-001 |

| ID | WBS | Activity | Type | Duration | Start | Finish | Predecessors | Total float | Free float | Resources | Cost | RESP - Responsibility | STRT%COMP for CM EVM | FNSH%COMP for CM EVM | CAM RESPONSIBLE | CR 10-060 | CR 11-026 | CR 12-007 | CR 13-002 | CR 07-024 | CR 12-054 | PHAS - Project Phase | CR 09-030 Repair | CR 12-053 | CR 08-016 | CR 09-012 | Profile change | CR 10-026 | CR 13-014 |
| --- | --- | --- | --- | --- | --- | --- | --- | --- | --- | --- | --- | --- | --- | --- | --- | --- | --- | --- | --- | --- | --- | --- | --- | --- | --- | --- | --- | --- | --- |
|  | 3 | **1.4.2.2.3 TIME OF FLIGHT** |  |  | 2009-10-01 | 2015-08-04 |  |  |  |  |  |  |  |  |  |  |  |  |  |  |  |  |  |  |  |  |  |  |  |
|  | 1 | **1.4.2.2.3.1 CENTRAL TOF** |  |  | 2010-07-01 | 2015-08-04 |  |  |  |  |  |  |  |  |  |  |  |  |  |  |  |  |  |  |  |  |  |  |  |
| 142231014 |  | CTOF Prepare Mezzanine workspace |  | 142d | 2010-07-01 | 2011-01-31 | 9-100M FS+184d | 665d |  | PROCUREMENT>$50K 69 NO ESCALATION FY11; PROCUREMENT<$50K 60 NO ESCALATION FY11 | 70,000 | ELOUADRHIRI L | 1 | 1 | LATIFA E | 10-060 | 11-026 | 12-007 | 13-002F |  |  |  |  |  |  |  |  |  |  |
| 142231005 |  | CTOF-P-#1 Prcrmnt of PMTs & Hi Voltage Dividers |  | 20d | 2010-10-01 | 2010-10-28 | 12222055, 9-110M, 12222055b, 12222045 | 723d |  |  |  | ELOUADRHIRI L | 1 | 1 | LATIFA E |  | 11-026 | 12-007 | 13-002F |  |  |  |  |  |  |  |  |  |  |
| 142231015 |  | CTOF-P-#1 Prcrmnt of Scintillators & Readout Sys |  | 20d | 2010-10-01 | 2010-10-28 | 9-110M, 12222055, 12222055b | 723d |  |  |  | ELOUADRHIRI L | 1 | 1 | LATIFA E |  | 11-026 | 12-007 | 13-002F |  |  |  |  |  |  |  |  |  |  |
| 142231012E |  | CTOF-FY12 Travel |  | 247d | 2011-10-03 | 2012-09-28 | 9-120M | 20d | 0d | TRAVEL | 5,850.04 | ELOUADRHIRI L | 1 | 1 | LATIFA E |  |  | 12-007 | 13-002F | 07-024 |  |  |  |  |  |  |  |  |  |
| 142231018M |  | CTOF Start Milestone | milestone | 0d | 2011-11-01 | 2011-11-01 | 9-120M FS+21d | 20d | 0d |  |  | ELOUADRHIRI L | 1 | 1 | LATIFA E |  | 11-026 | 12-007 | 13-002F |  | 12-054F |  |  |  |  |  |  |  |  |
| 142231020 |  | Prepare ALL 30 PR-LETTERS/CONTRACTS |  | 84d | 2011-11-01 | 2012-03-09 | 142231018M | 61d | 40d | SCIENTIST [180 h] | 12,709.8 | ELOUADRHIRI L | 1 | 1 | LATIFA E |  | 11-026 | 12-007 | 13-002F |  | 12-054F |  |  |  |  |  |  |  |  |
| 142231140 |  | Final Drawings of Tooling for wrapping |  | 75d | 2011-11-01 | 2012-02-27 | 142231018M | 34d | 0d | MECH DES [80 h] | 3,853.6 | ELOUADRHIRI L | 1 | 1 | LATIFA E |  | 11-026 | 12-007 | 13-002F |  | 12-054F |  |  |  |  |  |  |  |  |
| 142231150 |  | Purchase Clamps for Storage/Transport Racks |  | 46d | 2011-11-01 | 2012-01-13 | 142231018M | 94d | 0d | SUPPLIES & MATERIALS; MECH DES [8 h]; SCIENTIST [16 h] | 5,259.12 | ELOUADRHIRI L | 1 | 1 | LATIFA E |  | 11-026 | 12-007 | 13-002F |  | 12-054F |  |  |  |  |  |  |  |  |
| 142231155 |  | Purchase parts for Storage/Transportation racks |  | 33d | 2011-11-01 | 2011-12-19 | 142231018M | 107d | 13d | MECH DES [16 h]; SCIENTIST [16 h]; SUPPLIES & MATERIALS | 3,900.48 | ELOUADRHIRI L | 1 | 1 | LATIFA E |  | 11-026 | 12-007 | 13-002F |  | 12-054F |  |  |  |  |  |  |  |  |
| 142231160 |  | Final Drawings of Storage-Transportation Rack-25 LG |  | 30d | 2011-11-01 | 2011-12-14 | 142231018M | 110d | 16d | MECH DES [80 h] | 3,853.6 | ELOUADRHIRI L | 1 | 1 | LATIFA E |  | 11-026 | 12-007 | 13-002F |  | 12-054F |  |  |  |  |  |  |  |  |
| 142231185 |  | Purchase/Test/Shipping Acr.Rods to Plastic Craft |  | 33d | 2011-11-01 | 2011-12-19 | 142231018M | 82d | 0d | SCIENTIST [32 h]; PROCUREMENT<$50K 60 | 18,359.52 | ELOUADRHIRI L | 1 | 1 | LATIFA E |  | 11-026 | 12-007 | 13-002F |  | 12-054F | IN | 09-030 |  |  |  |  |  |  |
| 142231430 |  | Purchase incidentals/tools/material FY12 |  | 226d | 2011-11-01 | 2012-09-28 | 142231018M | 20d | 0d | SUPPLIES & MATERIALS | 10,195.5 | ELOUADRHIRI L | 1 | 1 | LATIFA E |  | 11-026 | 12-007 | 13-002F |  |  |  |  | 12-053 |  |  |  |  |  |
| 142231105 |  | Specify the Scintillator Quality |  | 37d | 2011-12-15 | 2012-02-14 | 142231018M FS+30d | 21d | 0d | SCIENTIST [16 h]; MECH DES [16 h] | 1,900.48 | ELOUADRHIRI L | 1 | 1 | LATIFA E |  | 11-026 | 12-007 | 13-002F |  | 12-054F |  |  |  |  |  |  |  |  |
| 142231190 |  | Purchase/Fabrication./Shipping Bent .LG's |  | 79d | 2011-12-20 | 2012-04-18 | 142231180 FS-60d, 142231185, 142231018M FS+20d | 125d | 105d | SCIENTIST [104 h]; PROCUREMENT<$50K 60; PROCUREMENT>$50K 69 | 77,343.44 | ELOUADRHIRI L | 1 | 1 | LATIFA E |  | 11-026 | 12-007 | 13-002F |  | 12-054F | IN | 09-030 |  |  |  |  |  |  |
| 142231130 |  | Final Drawings of Precision Gluing Frame-Table |  | 55d | 2012-01-06 | 2012-03-26 | 142231018M FS+40d | 20d | 0d | MECH DES [150 h] | 7,225.5 | ELOUADRHIRI L | 1 | 1 | LATIFA E |  | 11-026 | 12-007 | 13-002F |  | 12-054F |  |  |  | 08-016 | 09-012 |  |  |  |
| 142231225 |  | Final Drawings of Counter Support Arm Case |  | 90d | 2012-01-06 | 2012-05-14 | 142231018M FS+40d | 101d | 0d | MECH DES [150 h] | 7,225.5 | ELOUADRHIRI L | 1 | 1 | LATIFA E |  | 11-026 | 12-007 | 13-002F |  |  |  |  |  | 08-016 | 09-012 | C | 10-026 |  |
| 142231235 |  | Final Drawings of Counter Storage-25 Armed Counters |  | 44d | 2012-01-06 | 2012-03-09 | 142231018M FS+40d | 110d | 0d | MECH DES [80 h] | 3,853.6 | ELOUADRHIRI L | 1 | 1 | LATIFA E |  | 11-026 | 12-007 | 13-002F |  |  |  |  |  |  |  |  |  |  |
| 142231260 |  | Final Drawings of CTOF Support and Solenoid Harness |  | 112d | 2012-01-06 | 2012-06-15 | 142231018M FS+40d | 20d | 0d | MECH DES [200 h] | 9,634 | ELOUADRHIRI L | 1 | 1 | LATIFA E |  | 11-026 | 12-007 | 13-002F |  |  |  |  |  |  |  |  |  |  |
| 142231270 |  | Final Drawings of Counter installation Arm-Cart |  | 175d | 2012-01-06 | 2012-09-13 | 142231018M FS+40d | 20d | 0d | MECH DES [200 h] | 9,634 | ELOUADRHIRI L | 1 | 1 | LATIFA E |  | 11-026 | 12-007 | 13-002F |  | 12-054F |  |  |  |  |  |  |  |  |
| 142231280 |  | Final Drawings of Magnetic Shield Compensating Coil |  | 49d | 2012-01-06 | 2012-03-16 | 142231018M FS+40d | 107d | 0d | MECH DES [80 h] | 3,853.6 | ELOUADRHIRI L | 1 | 1 | LATIFA E |  | 11-026 | 12-007 | 13-002F |  |  | IN | 09-030 |  |  |  |  |  |  |
| 142231285 |  | Final Drawings of Magnetic Shield Components |  | 81d | 2012-01-06 | 2012-05-01 | 142231018M FS+40d | 95d | 0d | MECH DES [150 h] | 7,225.5 | ELOUADRHIRI L | 1 | 1 | LATIFA E |  | 11-026 | 12-007 | 13-002F |  |  | IN | 09-030 |  |  |  |  |  |  |
| 142231375 |  | Purchase/Fabricate/Ship PMT+Inner.Magn. Shield |  | 185d | 2012-01-09 | 2012-09-28 | 142231018M FS+41d | 97d | 0d | SCIENTIST [7 h]; PROCUREMENT<$50K 60; PROCUREMENT>$50K 69 | 233,494.27 | ELOUADRHIRI L | 1 | 1 | LATIFA E |  | 11-026 | 12-007 | 13-002F |  |  | IN | 09-030 |  |  |  |  |  |  |
| 142231330 |  | Purchase/Fabricate/Ship External Magnetic Shields FY12 |  | 183d | 2012-01-11 | 2012-09-28 | 142231018M FS+43d | 225d | 0d | SCIENTIST [85.28 h] | 6,021.62 | ELOUADRHIRI L | 1 | 1 | LATIFA E |  | 11-026 | 12-007 | 13-002F |  |  | IN | 09-030 | 12-053 |  |  |  |  |  |
| 142231330b |  | Purchase/Fabricate/Ship External Magnetic Shields Procurement |  | 206d | 2012-01-11 | 2012-10-31 | 142231018M FS+43d | 225d |  | PROCUREMENT<$50K 60 NO ESCALATION FY13 | 36,100 | ELOUADRHIRI L | 1 | 1 | LATIFA E |  | 11-026 | 12-007 | 13-002F |  |  | IN | 09-030 | 12-053 |  |  |  |  |  |
| 142231165 |  | Fabricate Storage-Transportation Rack-25 USLG |  | 15d | 2012-01-17 | 2012-02-06 | 142231160, 142231155, 142231150 | 94d | 0d | MECH TECH [12 h]; SUPPLIES & MATERIALS | 2,533.28 | ELOUADRHIRI L | 1 | 1 | LATIFA E |  | 11-026 | 12-007 | 13-002F |  | 12-054F | IN | 09-030 |  |  |  |  |  |  |
| 142231170 |  | Fabricate Storage-Transportation Rack-25 DSLG |  | 15d | 2012-01-17 | 2012-02-06 | 142231160, 142231150, 142231155 | 142d | 0d | MECH TECH [10 h]; SUPPLIES & MATERIALS | 2,444.4 | ELOUADRHIRI L | 1 | 1 | LATIFA E |  | 11-026 | 12-007 | 13-002F |  | 12-054F | IN | 09-030 |  |  |  |  |  |  |
| 142231175 |  | Shipping Racks to Company USLG |  | 15d | 2012-02-07 | 2012-02-28 | 142231165 | 94d | 0d | SCIENTIST [3 h]; SKLLD TRADE [16 h]; MECH TECH [16 h]; SUPPLIES & MATERIALS | 2,458.07 | ELOUADRHIRI L | 1 | 1 | LATIFA E |  | 11-026 | 12-007 | 13-002F |  | 12-054F | IN | 09-030 |  |  |  |  |  |  |
| 142231180 |  | Shipping Racks to Company DSLG |  | 15d | 2012-02-07 | 2012-02-28 | 142231175 FS-15d, 142231170 | 142d | 17d | MECH TECH [16 h]; SUPPLIES & MATERIALS; SCIENTIST [3 h]; SKLLD TRADE [16 h] | 2,458.07 | ELOUADRHIRI L | 1 | 1 | LATIFA E |  | 11-026 | 12-007 | 13-002F |  | 12-054F | IN | 09-030 |  |  |  |  |  |  |
| 142231200 |  | Purchase buffing tools and materials |  | 29d | 2012-02-14 | 2012-03-26 | 142231018M FS+66d | 20d | 0d | SUPPLIES & MATERIALS; SCIENTIST [32 h] | 3,259.52 | ELOUADRHIRI L | 1 | 1 | LATIFA E |  | 11-026 | 12-007 | 13-002F |  | 12-054F | IN | 09-030 |  |  |  |  |  |  |
| 142231110 |  | Purchase/Fabrication./Ship. Scintillators |  | 159d | 2012-02-15 | 2012-09-28 | 142231020 FS-57d, 142231105 | 21d | 1d | SCIENTIST [26 h]; PROCUREMENT<$50K 60; PROCUREMENT>$50K 69 | 61,835.86 | ELOUADRHIRI L | 1 | 1 | LATIFA E |  | 11-026 | 12-007 | 13-002F |  | 12-054F |  |  |  |  |  |  |  |  |
| 142231145 |  | Fabricate Tooling for Wrapping |  | 67d | 2012-02-28 | 2012-05-31 | 142231140 | 34d | 0d | MSHOP; MECH TECH [20 h]; SCIENTIST [20 h]; SKLLD TRADE [20 h] | 4,970 | ELOUADRHIRI L | 1 | 1 | LATIFA E |  | 11-026 | 12-007 | 13-002F |  | 12-054F |  |  |  |  |  |  |  |  |
| 142231335 |  | Purchase Cables and Connectors |  | 101d | 2012-03-09 | 2012-07-31 | 142231018M FS+83d | 94d | 0d | SCIENTIST [40 h]; PROCUREMENT<$50K 60 | 29,624.4 | ELOUADRHIRI L | 1 | 1 | LATIFA E |  | 11-026 | 12-007 | 13-002F |  |  | IN | 09-030 |  |  |  |  |  |  |
| 142231240 |  | Fabricate Storage Racks-25 Armed Counters FY12 |  | 142d | 2012-03-12 | 2012-09-28 | 142231235, 142231155, 142231150 | 110d | 0d | MECH TECH [39.72 h]; SKLLD TRADE [34.76 h]; SCIENTIST [3.97 h] | 3,208.2 | ELOUADRHIRI L | 1 | 1 | LATIFA E |  | 11-026 | 12-007 | 13-002F |  |  | IN | 09-030 | 12-053 |  |  |  |  |  |
| 142231290 |  | Purchase Coil components and materials |  | 39d | 2012-03-19 | 2012-05-10 | 142231280 | 107d | 0d | SUPPLIES & MATERIALS; SCIENTIST [6 h] | 8,423.66 | ELOUADRHIRI L | 1 | 1 | LATIFA E |  | 11-026 | 12-007 | 13-002F |  |  | IN | 09-030 |  |  |  |  |  |  |
| 142231345 |  | Final Drawings of Patch Panels for LV & HV;200 ch |  | 47d | 2012-03-20 | 2012-05-23 | 142231018M FS+90d | 95d | 0d | ELEC DES [40 h] | 2,020.4 | ELOUADRHIRI L | 1 | 1 | LATIFA E |  | 11-026 | 12-007 | 13-002F |  |  | IN | 09-030 |  |  |  |  |  |  |
| 142231350 |  | Final Drawings of Splitter to TDC and ADC; 100 ch |  | 47d | 2012-03-20 | 2012-05-23 | 142231018M FS+90d | 95d | 0d | ELEC DES [40 h] | 2,020.4 | ELOUADRHIRI L | 1 | 1 | LATIFA E |  | 11-026 | 12-007 | 13-002F |  |  | IN | 09-030 |  |  |  |  |  |  |
| 142231135 |  | Fabricate Precision Gluing-Frame-Table |  | 122d | 2012-03-27 | 2012-09-17 | 142231130 | 20d | 0d | MSHOP | 12,000 | ELOUADRHIRI L | 1 | 1 | LATIFA E |  | 11-026 | 12-007 | 13-002F |  | 12-054F | IN | 09-030 |  |  |  |  |  |  |
| 142231195 |  | Purchase/Fabrication./Shipping Straight .LG's |  | 67d | 2012-03-27 | 2012-06-29 | 142231018M FS+95d, 142231175, 142231185 | 75d | 55d | SCIENTIST [104 h]; PROCUREMENT<$50K 60; PROCUREMENT>$50K 69 | 75,843.44 | ELOUADRHIRI L | 1 | 1 | LATIFA E |  | 11-026 | 12-007 | 13-002F |  | 12-054F | IN | 09-030 |  |  |  |  |  |  |
| 142231205 |  | Purchase 900 shts, 12 sqin, VM2002, for wrapping |  | 46d | 2012-03-27 | 2012-05-30 | 142231018M FS+95d | 21d | 1d | SCIENTIST [8 h]; PROCUREMENT<$50K 60 | 16,364.88 | ELOUADRHIRI L | 1 | 1 | LATIFA E |  | 11-026 | 12-007 | 13-002F |  | 12-054F | IN | 09-030 |  |  |  |  |  |  |
| 142231210 |  | Purchase TEDLAR for wrapping |  | 33d | 2012-03-27 | 2012-05-10 | 142231018M FS+95d | 21d | 1d | SUPPLIES & MATERIALS; SCIENTIST [17 h] | 2,200.37 | ELOUADRHIRI L | 1 | 1 | LATIFA E |  | 11-026 | 12-007 | 13-002F |  | 12-054F | IN | 09-030 |  |  |  |  |  |  |
| 142231215 |  | Polishing/finishing LG |  | 122d | 2012-03-27 | 2012-09-17 | 142231200, 142231205 FS-47d, 142231210 FS-34d, 142231185 | 20d | 0d | SCIENTIST [40 h]; SUPPLIES & MATERIALS; MECH TECH [320 h] | 20,545.2 | ELOUADRHIRI L | 1 | 1 | LATIFA E |  | 11-026 | 12-007 | 13-002F |  | 12-054F | IN | 09-030 |  |  |  |  |  |  |
| 142231415 |  | Assemble the DAQ system FY12 |  | 120d | 2012-04-11 | 2012-09-28 | 142231375 FS-120d | 108d | 0d | SCIENTIST [38.4 h]; MECH TECH [19.2 h] | 3,564.67 | ELOUADRHIRI L | 1 | 1 | LATIFA E |  | 11-026 | 12-007 | 13-002F |  |  | IN | 09-030 | 12-053 |  |  |  |  |  |
| 142231115 |  | Refurbish Laser Calibration System FY12 |  | 117d | 2012-04-16 | 2012-09-28 | 142231105 FS+42d | 107d | 0d | SCIENTIST [23.59 h]; MECH DES [18.87 h]; MECH TECH [23.59 h]; SKLLD TRADE [9.44 h]; SUPPLIES & MATERIALS | 7,712.96 | ELOUADRHIRI L | 1 | 1 | LATIFA E |  | 11-026 | 12-007 | 13-002F |  |  |  |  | 12-053 |  |  |  |  |  |
| 142231300 |  | Purchase/Fabricate/Ship Middle.Magn. Shield FY12 |  | 105d | 2012-05-02 | 2012-09-28 | 142231285 | 95d | 0d | SCIENTIST [4.92 h] | 347.4 | ELOUADRHIRI L | 1 | 1 | LATIFA E |  | 11-026 | 12-007 | 13-002F |  |  | IN | 09-030 | 12-053 |  |  |  |  |  |
| 142231300b |  | Purchase/Fabricate/Ship Middle.Magn. Shield Procurement |  | 128d | 2012-05-02 | 2012-10-31 | 142231285 | 95d | 69d | PROCUREMENT<$50K 60 NO ESCALATION FY13 | 29,500 | ELOUADRHIRI L | 1 | 1 | LATIFA E |  | 11-026 | 12-007 | 13-002F |  |  | IN | 09-030 | 12-053 |  |  |  |  |  |
| 142231305 |  | Purchase/Fabricate/Ship Middle. Magn. Disks FY12 |  | 105d | 2012-05-02 | 2012-09-28 | 142231285 | 95d | 0d | SCIENTIST [4.92 h] | 347.4 | ELOUADRHIRI L | 1 | 1 | LATIFA E |  | 11-026 | 12-007 | 13-002F |  |  | IN | 09-030 | 12-053 |  |  |  |  |  |
| 142231305b |  | Purchase/Fabricate/Ship Middle. Magn. Disks Procurement |  | 128d | 2012-05-02 | 2012-10-31 | 142231285 | 95d | 69d | PROCUREMENT<$50K 60 NO ESCALATION FY13 | 17,200 | ELOUADRHIRI L | 1 | 1 | LATIFA E |  | 11-026 | 12-007 | 13-002F |  |  | IN | 09-030 | 12-053 |  |  |  |  |  |
| 142231310 |  | Purchase/Fabricate/Ship Inner. Magn. Disks FY12 |  | 105d | 2012-05-02 | 2012-09-28 | 142231285 | 95d | 0d | SCIENTIST [4.92 h] | 347.4 | ELOUADRHIRI L | 1 | 1 | LATIFA E |  | 11-026 | 12-007 | 13-002F |  |  | IN | 09-030 | 12-053 |  |  |  |  |  |
| 142231310b |  | Purchase/Fabricate/Ship Inner. Magn. Disks Procurement |  | 128d | 2012-05-02 | 2012-10-31 | 142231285 | 95d | 69d | PROCUREMENT<$50K 60 NO ESCALATION FY13 | 11,300 | ELOUADRHIRI L | 1 | 1 | LATIFA E |  | 11-026 | 12-007 | 13-002F |  |  | IN | 09-030 | 12-053 |  |  |  |  |  |
| 142231295 |  | Fabricate Compensating Coil FY12 |  | 98d | 2012-05-11 | 2012-09-28 | 142231280, 142231290 | 107d | 0d | SCIENTIST [12.35 h]; MSHOP; MECH TECH [12.35 h]; SKLLD TRADE [41.18 h] | 11,033.63 | ELOUADRHIRI L | 1 | 1 | LATIFA E |  | 11-026 | 12-007 | 13-002F |  |  | IN | 09-030 | 12-053 |  |  |  |  |  |
| 142231230 |  | Fabricate Counter-Support-Arm -Case FY12 |  | 96d | 2012-05-15 | 2012-09-28 | 142231225 | 101d | 0d | MECH DES [36.23 h]; MSHOP; MECH TECH [72.45 h]; SCIENTIST [36.23 h]; SKLLD TRADE [235.47 h] | 29,527.85 | ELOUADRHIRI L | 1 | 1 | LATIFA E |  | 11-026 | 12-007 | 13-002F |  |  |  |  | 12-053 | 08-016 | 09-012 | C | 10-026 |  |
| 142231355 |  | Fabricate Patch Panels for LV&HV FY12 |  | 89d | 2012-05-24 | 2012-09-28 | 142231345, 142231350 | 95d | 0d | ELEC TECH [15.91 h]; SKLLD TRADE [7.96 h] | 968.37 | ELOUADRHIRI L | 1 | 1 | LATIFA E |  | 11-026 | 12-007 | 13-002F |  |  | IN | 09-030 | 12-053 |  |  |  |  |  |
| 142231360 |  | Fabricate Splitter Parts FY12 |  | 89d | 2012-05-24 | 2012-09-28 | 142231345, 142231350 | 95d | 0d | ELEC TECH [44.85 h]; SCIENTIST [44.85 h]; SKLLD TRADE [11.21 h] | 5,521.06 | ELOUADRHIRI L | 1 | 1 | LATIFA E |  | 11-026 | 12-007 | 13-002F |  |  | IN | 09-030 | 12-053 |  |  |  |  |  |
| 142231220 |  | Wrapping and Transmittance test of LG |  | 61d | 2012-06-01 | 2012-08-27 | 142231200, 142231205 FS-31d, 142231210 FS-20d, 142231145 | 34d | 14d | SCIENTIST [52 h]; MECH TECH [120 h]; CONTRB UNIV LBR [1720 h] | 9,004.52 | ELOUADRHIRI L | 1 | 1 | LATIFA E |  | 11-026 | 12-007 | 13-002F |  | 12-054F |  |  |  |  |  |  |  |  |
| 142231120 |  | Purchase OMNICURE S2000 UV Curing system |  | 65d | 2012-06-15 | 2012-09-14 | 142231018M FS+151d | 21d | 1d | SCIENTIST [4 h]; SUPPLIES & MATERIALS | 6,782.44 | ELOUADRHIRI L | 1 | 1 | LATIFA E |  | 11-026 | 12-007 | 13-002F |  | 12-054F |  |  |  |  |  |  |  |  |
| 142231125 |  | Purchase UV Glue, Tooling and Materials |  | 65d | 2012-06-15 | 2012-09-14 | 142231018M FS+151d | 21d | 1d | SCIENTIST [4 h]; SUPPLIES & MATERIALS | 3,282.44 | ELOUADRHIRI L | 1 | 1 | LATIFA E |  | 11-026 | 12-007 | 13-002F |  | 12-054F |  |  |  |  |  |  |  |  |
| 142231265 |  | Fabricate Solenoid Harness FY12 |  | 74d | 2012-06-18 | 2012-09-28 | 142231260 | 20d | 0d | MSHOP; MECH TECH [7.12 h]; SKLLD TRADE [56.92 h] | 6,963.97 | ELOUADRHIRI L | 1 | 1 | LATIFA E |  | 11-026 | 12-007 | 13-002F |  |  |  |  | 12-053 |  |  |  |  |  |
| 142231380 |  | Testing the PMT timing performance FY12 |  | 60d | 2012-07-06 | 2012-09-28 | 142231375 FS-60d | 97d | 0d | SCIENTIST [58.6 h]; CONTRB UNIV LBR [1214.25 h] | 4,137.75 | ELOUADRHIRI L | 1 | 1 | LATIFA E |  | 11-026 | 12-007 | 13-002F |  |  | IN | 09-030 | 12-053 |  |  |  |  |  |
| 142231340 |  | Fabricate Cables LV&HV FY12 |  | 42d | 2012-08-01 | 2012-09-28 | 142231335 | 94d | 0d | ELEC TECH [33.16 h] | 1,463.35 | ELOUADRHIRI L | 1 | 1 | LATIFA E |  | 11-026 | 12-007 | 13-002F |  |  | IN | 09-030 | 12-053 |  |  |  |  |  |
| 142231245 |  | Two-side glue Counters in Support Arm FY12 |  | 9d | 2012-09-18 | 2012-09-28 | 142231195, 142231110 FS-10d, 142231220, 142231125, 142231215, 142231135, 142231190, 142231120 | 20d | 0d | SCIENTIST [12.97 h]; MECH TECH [12.97 h] | 1,492.2 | ELOUADRHIRI L | 1 | 1 | LATIFA E |  | 11-026 | 12-007 | 13-002F |  | 12-054F |  |  | 12-053 |  |  |  |  |  |
| 142231013E |  | CTOF-FY13 Travel |  | 228d | 2012-10-01 | 2013-08-30 | 142231012E | 20d |  | TRAVEL | 5,572.3 | ELOUADRHIRI L | 1 | 1 | LATIFA E |  |  | 12-007 | 13-002F | 07-024 |  |  |  |  |  |  |  |  | 13-014 |
| 142231115a |  | Refurbish Laser Calibration System FY13 |  | 131d | 2012-10-01 | 2013-04-15 | 142231115 | 107d | 87d | SCIENTIST [26.41 h]; MECH DES [21.13 h]; MECH TECH [26.41 h]; SKLLD TRADE [10.56 h]; SUPPLIES & MATERIALS | 8,910.9 | ELOUADRHIRI L | 1 | 1 | LATIFA E |  | 11-026 | 12-007 | 13-002F |  |  |  |  | 12-053 |  |  |  |  |  |
| 142231230a |  | Fabricate Counter-Support-Arm -Case FY13 |  | 10d | 2012-10-01 | 2012-10-12 | 142231230 | 101d | 0d | SCIENTIST [3.77 h]; SKLLD TRADE [24.53 h]; MECH DES [3.77 h]; MSHOP; MECH TECH [7.55 h] | 3,173.76 | ELOUADRHIRI L | 1 | 1 | LATIFA E |  | 11-026 | 12-007 | 13-002F |  |  |  |  | 12-053 | 08-016 | 09-012 | C | 10-026 |  |
| 142231240a |  | Fabricate Storage Racks-25 Armed Counters FY13 |  | 1d | 2012-10-01 | 2012-10-01 | 142231240 | 110d | 9d | MECH TECH [0.28 h]; SKLLD TRADE [0.24 h]; SCIENTIST [0.03 h] | 23.31 | ELOUADRHIRI L | 1 | 1 | LATIFA E |  | 11-026 | 12-007 | 13-002F |  |  | IN | 09-030 | 12-053 |  |  |  |  |  |
| 142231245a |  | Two-side glue Counters in Support Arm FY13 |  | 102d | 2012-10-01 | 2013-03-05 | 142231190, 142231120, 142231245, 142231110 FS-10d, 142231220, 142231215, 142231125, 142231135, 142231195 | 20d | 0d | SCIENTIST [147.03 h]; MECH TECH [147.03 h] | 17,455.41 | ELOUADRHIRI L | 1 | 1 | LATIFA E |  | 11-026 | 12-007 | 13-002F |  | 12-054F |  |  | 12-053 |  |  |  |  |  |
| 142231265a |  | Fabricate Solenoid Harness FY13 |  | 228d | 2012-10-01 | 2013-08-30 | 142231265 | 20d |  | MSHOP; MECH TECH [21.92 h]; SKLLD TRADE [175.39 h] | 22,141.32 | ELOUADRHIRI L | 1 | 1 | LATIFA E |  | 11-026 | 12-007 | 13-002F |  |  |  |  | 12-053 |  |  |  |  | 13-014 |
| 142231295a |  | Fabricate Compensating Coil FY13 |  | 21d | 2012-10-01 | 2012-10-29 | 142231295 | 107d | 81d | SCIENTIST [2.65 h]; MSHOP; MECH TECH [2.65 h]; SKLLD TRADE [8.82 h] | 2,440.07 | ELOUADRHIRI L | 1 | 1 | LATIFA E |  | 11-026 | 12-007 | 13-002F |  |  | IN | 09-030 | 12-053 |  |  |  |  |  |
| 142231300a |  | Purchase/Fabricate/Ship Middle.Magn. Shield FY13 |  | 23d | 2012-10-01 | 2012-10-31 | 142231300 | 95d | 69d | SCIENTIST [1.08 h] | 78.69 | ELOUADRHIRI L | 1 | 1 | LATIFA E |  | 11-026 | 12-007 | 13-002F |  |  | IN | 09-030 | 12-053 |  |  |  |  |  |

| ID | Activity | Duration | Start | Finish | Predecessors | Total float | Free float | Calendar | Resources | Cost | PHAS - Project Phase | RESP - Responsibility | STRT%COMP for CM EVM | FNSH%COMP for CM EVM | CAM RESPONSIBLE | CR 09-030 Repair | CR 11-026 | CR 12-007 | CR 12-053 | CR 13-002 | CR 12-027 | CR 12-054 | CR 13-014 | ReBaseline Actuals Adjustment | Original Activity ID Rebaseline | CR 07-024 | EVMS Reporting Codes | BOE Expenses | CR 13-015 | Post Rebaseline | Over Under Fixed | BOE Procurement | BOE Labor | Obligated Prior to Rebaseline | CR 14-001 | Activities with Steps |
| --- | --- | --- | --- | --- | --- | --- | --- | --- | --- | --- | --- | --- | --- | --- | --- | --- | --- | --- | --- | --- | --- | --- | --- | --- | --- | --- | --- | --- | --- | --- | --- | --- | --- | --- | --- | --- |
| 142231305a | Purchase/Fabricate/Ship Middle. Magn. Disks FY13 | 23d | 2012-10-01 | 2012-10-31 | 142231305 | 95d | 69d |  | SCIENTIST [1.08 h] | 78.69 | IN | ELOUADRHIRI L | 1 | 1 | LATIFA E | 09-030 | 11-026 | 12-007 | 12-053 | 13-002F |  |  |  |  |  |  |  |  |  |  |  |  |  |  |  |  |
| 142231310a | Purchase/Fabricate/Ship Inner. Magn. Disks FY13 | 23d | 2012-10-01 | 2012-10-31 | 142231310 | 95d | 69d |  | SCIENTIST [1.08 h] | 78.69 | IN | ELOUADRHIRI L | 1 | 1 | LATIFA E | 09-030 | 11-026 | 12-007 | 12-053 | 13-002F |  |  |  |  |  |  |  |  |  |  |  |  |  |  |  |  |
| 142231320 | Purchase DCPS 6030A 200V/17A Ext.Magn. Shield | 110d | 2012-10-01 | 2013-03-15 | 9-130M, 142231018M FS+10d | 25d | 0d |  | SCIENTIST [32 h]; PROCUREMENT<$50K 60 | 15,333.46 | IN | ELOUADRHIRI L | 1 | 1 | LATIFA E | 09-030 | 11-026 | 12-007 |  | 13-002F | 12-027 | 12-054F |  |  |  |  |  |  |  |  |  |  |  |  |  |  |
| 142231330a | Purchase/Fabricate/Ship External Magnetic Shields FY13 | 23d | 2012-10-01 | 2012-10-31 | 142231330 | 225d |  |  | SCIENTIST [10.72 h] | 781.06 | IN | ELOUADRHIRI L | 1 | 1 | LATIFA E | 09-030 | 11-026 | 12-007 | 12-053 | 13-002F |  |  |  |  |  |  |  |  |  |  |  |  |  |  |  |  |
| 142231340a | Fabricate Cables LV&HV FY13 | 34d | 2012-10-01 | 2012-11-15 | 142231340 | 94d | 68d |  | ELEC TECH [26.84 h] | 1,222.29 | IN | ELOUADRHIRI L | 1 | 1 | LATIFA E | 09-030 | 11-026 | 12-007 | 12-053 | 13-002F |  |  |  |  |  |  |  |  |  |  |  |  |  |  |  |  |
| 142231355a | Fabricate Patch Panels for LV&HV FY13 | 90d | 2012-10-01 | 2013-02-14 | 142231355 | 95d | 0d |  | ELEC TECH [16.09 h]; SKLLD TRADE [8.04 h] | 1,010.28 | IN | ELOUADRHIRI L | 1 | 1 | LATIFA E | 09-030 | 11-026 | 12-007 | 12-053 | 13-002F |  |  |  |  |  |  |  |  |  |  |  |  |  |  |  |  |
| 142231360a | Fabricate Splitter Parts FY13 | 38d | 2012-10-01 | 2012-11-21 | 142231360 | 95d | 0d |  | ELEC TECH [19.15 h]; SCIENTIST [19.15 h]; SKLLD TRADE [4.79 h] | 2,432.71 | IN | ELOUADRHIRI L | 1 | 1 | LATIFA E | 09-030 | 11-026 | 12-007 | 12-053 | 13-002F |  |  |  |  |  |  |  |  |  |  |  |  |  |  |  |  |
| 142231380a | Testing the PMT timing performance FY13 | 25d | 2012-10-01 | 2012-11-02 | 142231375 FS-60d, 142231380 | 97d | 77d |  | SCIENTIST [24.41 h]; CONTRB UNIV LBR [505.94 h] | 1,778.51 | IN | ELOUADRHIRI L | 1 | 1 | LATIFA E | 09-030 | 11-026 | 12-007 | 12-053 | 13-002F |  |  |  |  |  |  |  |  |  |  |  |  |  |  |  |  |
| 142231415a | Assemble the DAQ system FY13 | 130d | 2012-10-01 | 2013-04-12 | 142231415 | 108d | 88d |  | MECH TECH [20.8 h]; SCIENTIST [41.6 h] | 3,984.87 | IN | ELOUADRHIRI L | 1 | 1 | LATIFA E | 09-030 | 11-026 | 12-007 | 12-053 | 13-002F |  |  |  |  |  |  |  |  |  |  |  |  |  |  |  |  |
| 142231430a | Purchase incidentals/tools/material FY13 | 228d | 2012-10-01 | 2013-08-30 | 142231018M, 142231430 | 20d |  |  | SUPPLIES & MATERIALS | 10,613.82 |  | ELOUADRHIRI L | 1 | 1 | LATIFA E |  | 11-026 | 12-007 | 12-053 | 13-002F |  |  | 13-014 |  |  |  |  |  |  |  |  |  |  |  |  |  |
| 142231250 | Counter-in-rack storage and wrapping | 98d | 2012-10-15 | 2013-03-13 | 142231135, 142231215, 142231145, 142231125, 142231120, 142231220, 142231240a, 142231190, 142231110 FS-10d, 142231230a, 142231195 | 101d | 81d |  | SCIENTIST [26 h]; MECH TECH [104 h] | 6,663.8 |  | ELOUADRHIRI L | 1 | 1 | LATIFA E |  | 11-026 | 12-007 |  | 13-002F |  |  |  |  |  |  |  |  |  |  |  |  |  |  |  |  |
| 142231255 | Transmittance test of assembled Counters in Rack | 98d | 2012-10-15 | 2013-03-13 | 142231190, 142231230a, 142231135, 142231215, 142231125, 142231110 FS-10d, 142231240a, 142231195, 142231220, 142231120 | 101d | 81d |  | SCIENTIST [104 h]; CONTRB UNIV LBR [1720 h] | 7,577.44 |  | ELOUADRHIRI L | 1 | 1 | LATIFA E |  | 11-026 | 12-007 |  | 13-002F |  |  |  |  |  |  |  |  |  |  |  |  |  |  |  |  |
| 142231370 | Assembling of the CTOF splitters | 105d | 2012-11-26 | 2013-05-01 | 142231360a | 95d | 75d |  | SCIENTIST [10.91 h]; MECH TECH [109.09 h] | 5,797.75 | IN | ELOUADRHIRI L | 1 | 1 | LATIFA E | 09-030 | 11-026 | 12-007 |  | 13-002F |  |  |  |  |  |  |  |  |  |  |  |  |  |  |  |  |
| 142231315 | Purchase Magnet for Magnetic Shields Tests | 110d | 2013-01-10 | 2013-06-17 | 142231018M FS+10d, 9-130M FS+65d | 25d | 0d |  | SCIENTIST [48 h]; PROCUREMENT>$50K 69; PROCUREMENT<$50K 60 | 51,578.66 | IN | ELOUADRHIRI L | 1 | 1 | LATIFA E | 09-030 | 11-026 | 12-007 |  | 13-002F | 12-027 | 12-054 |  |  |  |  |  |  |  |  |  |  |  |  |  |  |
| 142231365 | Assembling of the CTOF patch panels | 53d | 2013-02-15 | 2013-05-01 | 142231355a | 95d | 75d |  | MECH TECH [8 h]; SCIENTIST [8 h] | 949.76 | IN | ELOUADRHIRI L | 1 | 1 | LATIFA E | 09-030 | 11-026 | 12-007 |  | 13-002F |  |  |  |  |  |  |  |  |  |  |  |  |  |  |  |  |
| 142231325 | Assemble the Setup for Magnetic Shields Tests | 123d | 2013-03-04 | 2013-08-23 | 142231320 FS-10d, 142231315 FS-75d | 25d |  |  | SCIENTIST [96 h]; ELEC TECH [48 h]; CONTRB UNIV LBR [1720 h] | 9,180.48 | IN | ELOUADRHIRI L | 1 | 1 | LATIFA E | 09-030 | 11-026 | 12-007 |  | 13-002F | 12-027 | 12-054F |  |  |  |  |  |  |  |  |  |  |  |  |  |  |
| 142231390 | Install PMT and check the orientation | 116d | 2013-03-06 | 2013-08-16 | 142231380, 142231245a, 142231380a | 20d | 0d |  | SCIENTIST [104 h]; MECH TECH [104 h] | 12,346.88 | IN | ELOUADRHIRI L | 1 | 1 | LATIFA E | 09-030 | 11-026 | 12-007 |  | 13-002F |  | 12-054 |  |  |  |  |  |  |  |  |  |  |  |  |  |  |
| 142231395 | Install shield disks onto the Light guides | 108d | 2013-03-06 | 2013-08-06 | 142231300a, 142231305b, 142231305a, 142231310a, 142231310b, 142231245a, 142231300b | 28d | 8d |  | SCIENTIST [104 h]; MECH TECH [208 h] | 17,116.32 | IN | ELOUADRHIRI L | 1 | 1 | LATIFA E | 09-030 | 11-026 | 12-007 |  | 13-002F |  | 12-054 |  |  |  |  |  |  |  |  |  |  |  |  |  |  |
| 142231400 | Install compensation coils and check polarity | 110d | 2013-03-06 | 2013-08-08 | 142231245a, 142231295a | 26d | 6d |  | MECH TECH [52 h]; SCIENTIST [52 h] | 6,173.44 | IN | ELOUADRHIRI L | 1 | 1 | LATIFA E | 09-030 | 11-026 | 12-007 |  | 13-002F |  | 12-054 |  |  |  |  |  |  |  |  |  |  |  |  |  |  |
| 142231405 | Install Middle. Mag. Shields onto PMT | 110d | 2013-03-06 | 2013-08-08 | 142231305b, 142231310b, 142231300b, 142231300a, 142231245a, 142231305a, 142231310a | 26d | 6d |  | SCIENTIST [104 h]; MECH TECH [104 h] | 12,346.88 | IN | ELOUADRHIRI L | 1 | 1 | LATIFA E | 09-030 | 11-026 | 12-007 |  | 13-002F |  | 12-054 |  |  |  |  |  |  |  |  |  |  |  |  |  |  |
| 142231410 | CTOF in Storage Rack cabling | 110d | 2013-03-06 | 2013-08-08 | 142231310b FS+10d, 142231380, 142231300b FS+10d, 142231340a, 142231380a, 142231310a FS+10d, 142231335, 142231300a FS+10d, 142231305a FS+10d, 142231305b FS+10d, 142231245a | 26d | 6d |  | SCIENTIST [20 h]; MECH TECH [40 h] | 3,291.6 | IN | ELOUADRHIRI L | 1 | 1 | LATIFA E | 09-030 | 11-026 | 12-007 |  | 13-002F |  | 12-054 |  |  |  |  |  |  |  |  |  |  |  |  |  |  |
| 142231275 | Fabricate Counter-Installation-Arm -Cart | 119d | 2013-03-15 | 2013-08-30 | 142231270 FS+120d | 20d |  |  | MECH TECH [23.99 h]; SCIENTIST [4.8 h]; SKLLD TRADE [23.99 h]; MSHOP | 7,724.59 |  | ELOUADRHIRI L | 1 | 1 | LATIFA E |  | 11-026 | 12-007 | 12-053 | 13-002F |  | 12-054 | 13-014 |  |  |  |  |  |  |  |  |  |  |  |  |  |
| 142231420 | Standalone CTOF testing/optimizing | 10d | 2013-08-19 | 2013-08-30 | 142231370, 142231115a, 142231405, 142231410, 142231400, 142231395, 142231245a FS+29d, 142231415a, 142231245 FS+29d, 142231250 FS+29d, 142231255 FS+29d, 142231390, 142231365 | 20d |  |  | SCIENTIST [13.89 h]; CONTRB UNIV LBR [162.96 h] | 1,011.93 |  | ELOUADRHIRI L | 1 | 1 | LATIFA E |  | 11-026 | 12-007 |  | 13-002F |  | 12-054 | 13-014 |  |  |  |  |  |  |  |  |  |  |  |  |  |
| 142231475 | Re-Baseline Actuals Adjustment | 1d | 2013-08-30 | 2013-08-30 | 9-130M FS+227d | 20d |  |  | PROCUREMENT>$50K 69 NO ESCALATION | -261,730.13 |  | ELOUADRHIRI L | 1 | 1 | LATIFA E |  |  |  |  |  |  |  | 13-014 | ADJ |  |  |  |  |  |  |  |  |  |  |  |  |
| 242231013E | CTOF-FY13 Travel | 20d | 2013-09-03 | 2013-09-30 | 9-130M FS+228d | 498d | 453d | 8/5 M-F w/JLAB Holidays ReBaseline | TRAVEL | 485.41 |  | ELOUADRHIRI L | 1 | 1 | LATIFA E |  |  | 12-007 |  | 13-002F |  |  |  |  | 242231013E | 07-024 | E | PE | 13-015 | PR |  |  |  |  |  |  |
| 242231120 | Refurbish Laser Calibration System FY 13 Obligated Procurement | 20d | 2013-09-03 | 2013-09-30 | 9-130M FS+228d | 499d | 454d | 8/5 M-F w/JLAB Holidays ReBaseline | PROCUREMENT<$50K 60 | 70.38 |  | ELOUADRHIRI L | 1 | 1 | LATIFA E |  | 11-026 | 12-007 | 12-053 | 13-002F |  |  |  |  | 242231115 |  | U | PE | 13-015 | PR | y | PE | PE | OB |  |  |
| 242231140 | Final Drawings of Tooling for wrapping | 57d | 2013-10-01 | 2013-12-20 | 9-140M | 121d | 0d | 8/5 M-F w/JLAB Holidays ReBaseline | MECH DES [40 h] | 2,052 |  | ELOUADRHIRI L | 1 | 1 | LATIFA E |  | 11-026 | 12-007 |  | 13-002F |  | 12-054F |  |  | 242231140 |  | H |  | 13-015 | PR |  |  | PE |  | 14-001 |  |
| 242231215 | Polishing/finishing LG | 58d | 2013-10-01 | 2014-01-02 | 9-140M, 242231200 FS-140d, 242231205 FS-140d | 133d | 0d | 8/5 M-F w/JLAB Holidays ReBaseline | SCIENTIST [32 h]; MECH TECH [88 h]; MSHOP; VISTNG USERS [160 h] | 11,020.05 | IN | ELOUADRHIRI L | 1 | 1 | LATIFA E | 09-030 | 11-026 | 12-007 |  | 13-002F |  | 12-054F |  |  | 242231215 |  | U | PE | 13-015 | PR |  |  | PE |  | 14-001 |  |
| 242231115 | Refurbish Laser Calibration System | 225d | 2013-10-03 | 2014-09-02 | 9-140M FS+2d | 272d | 227d | 8/5 M-F w/JLAB Holidays ReBaseline | SCIENTIST [102 h]; MECH DES [102 h]; MECH TECH [102 h]; SUPPLIES & MATERIALS | 24,862.93 |  | ELOUADRHIRI L | 1 | 1 | LATIFA E |  | 11-026 | 12-007 | 12-053 | 13-002F |  |  |  |  | 242231115 |  | U | PE | 13-015 | PR |  | PE | PE |  | 14-001 |  |
| 242231125 | Purchase UV Glue, Tooling and Materials | 203d | 2013-10-03 | 2014-07-31 | 9-140M FS+2d | 174d | 53d | 8/5 M-F w/JLAB Holidays ReBaseline | SUPPLIES & MATERIALS | 1,346.63 |  | ELOUADRHIRI L | 1 | 1 | LATIFA E |  | 11-026 | 12-007 |  | 13-002F |  | 12-054F |  |  | 242231125 |  | D | PE | 13-015 | PR |  | PE |  |  | 14-001 |  |
| 242231200 | Purchase buffing tools and materials | 77d | 2013-10-03 | 2014-02-03 | 9-140M FS+2d | 194d | 61d | 8/5 M-F w/JLAB Holidays ReBaseline | SUPPLIES & MATERIALS; SCIENTIST [9.96 h] | 5,324.23 | IN | ELOUADRHIRI L | 1 | 1 | LATIFA E | 09-030 | 11-026 | 12-007 |  | 13-002F |  | 12-054F |  |  | 242231200 |  | D | PE | 13-015 | PR |  | PE | PE |  | 14-001 |  |
| 242231205 | Purchase 900 shts, 12 sqin, VM2002, for wrapping | 77d | 2013-10-03 | 2014-02-03 | 9-140M FS+2d | 183d | 61d | 8/5 M-F w/JLAB Holidays ReBaseline | PROCUREMENT<$50K 60 | 2,568.92 | IN | ELOUADRHIRI L | 1 | 1 | LATIFA E | 09-030 | 11-026 | 12-007 |  | 13-002F |  | 12-054F |  |  | 242231205 |  | D |  | 13-015 | PR |  | CP |  |  | 14-001 |  |
| 242231260 | Final Drawings of CTOF Support and Solenoid Harness | 156d | 2013-10-03 | 2014-05-23 | 9-140M FS+2d | 172d | 0d | 8/5 M-F w/JLAB Holidays ReBaseline | MECH DES [160 h] | 8,208 |  | ELOUADRHIRI L | 1 | 1 | LATIFA E |  | 11-026 | 12-007 |  | 13-002F |  |  |  |  | 242231260 |  | S |  | 13-015 | PR |  |  | PE |  | 14-001 | ST |
| 242231220 | Wrapping and Transmittance test of LG | 70d | 2013-10-04 | 2014-01-24 | 242231215 FS-55d | 133d | 0d | 8/5 M-F w/JLAB Holidays ReBaseline | MECH TECH [240 h]; VISTNG USERS [240 h] | 16,298.4 |  | ELOUADRHIRI L | 1 | 1 | LATIFA E |  | 11-026 | 12-007 |  | 13-002F |  | 12-054F |  |  | 242231220 |  | U |  | 13-015 | PR |  |  | PE |  | 14-001 |  |
| 242231270 | Final drawings for counter installation arm - cart and transport rack | 233d | 2013-10-28 | 2014-10-07 | 242231260 FS-139d | 172d | 0d | 8/5 M-F w/JLAB Holidays ReBaseline | MECH DES [480 h] | 24,624 |  | ELOUADRHIRI L | 1 | 1 | LATIFA E |  | 11-026 | 12-007 |  | 13-002F |  | 12-054F |  |  | 242231270 |  | S |  | 13-015 | PR |  |  | PE |  | 14-001 | ST |
| 242231145 | Fabricate Tooling for Wrapping | 55d | 2013-10-29 | 2014-01-28 | 242231140 FS-37d | 121d | 0d | 8/5 M-F w/JLAB Holidays ReBaseline | MECH TECH [40 h]; MSHOP | 4,457.07 |  | ELOUADRHIRI L | 1 | 1 | LATIFA E |  | 11-026 | 12-007 |  | 13-002F |  | 12-054F |  |  | 242231145 |  | S | PE | 13-015 | PR |  |  | PE |  | 14-001 | ST |
| 242231460 | Purchase stabilized dividers for H2431 PMTs | 77d | 2013-11-04 | 2014-03-05 | 9-140M FS+24d | 242.5d | 0d | 8/5 M-F w/JLAB Holidays ReBaseline | PROCUREMENT<$50K 60 | 4,323.15 |  | ELOUADRHIRI L | 1 | 1 | LATIFA E |  | 11-026 | 12-007 | 12-053 | 13-002F |  |  |  |  | 242231460 |  | U |  | 13-015 | PR |  | PE |  |  | 14-001 |  |
| 242231285 | Final Drawings of Magnetic Shield Components | 58d | 2013-11-21 | 2014-02-25 | 9-140M FS+37d | 192d | 0d | 8/5 M-F w/JLAB Holidays ReBaseline | MECH DES [200 h] | 10,260 | IN | ELOUADRHIRI L | 1 | 1 | LATIFA E | 09-030 | 11-026 | 12-007 |  | 13-002F |  |  |  |  | 242231285 |  | S |  | 13-015 | PR |  |  | PE |  | 14-001 | ST |
| 242231280 | Final Drawings of Magnetic Shield Compensating Coil | 49d | 2013-12-06 | 2014-02-25 | 9-140M FS+46d | 206d | 0d | 8/5 M-F w/JLAB Holidays ReBaseline | MECH DES [120 h] | 6,156 | IN | ELOUADRHIRI L | 1 | 1 | LATIFA E | 09-030 | 11-026 | 12-007 |  | 13-002F |  |  |  |  | 242231280 |  | H |  | 13-015 | PR |  |  | PE |  | 14-001 |  |
| 242231287 | Magnetic Shield Engineering Analysis | 21d | 2013-12-20 | 2014-01-30 | 242231285 FS-39d | 210d | 18d | 8/5 M-F w/JLAB Holidays ReBaseline | MECH ENG [120 h] | 8,960.4 | IN | ELOUADRHIRI L | 1 | 1 | LATIFA E | 09-030 | 11-026 | 12-007 |  | 13-002F |  |  |  |  | 242231287 |  | H |  | 13-015 | PR |  |  | PE |  | 14-001 |  |
| 242231262 | CTOF Support and Solenoid Harness Engineer analysis | 117d | 2014-01-10 | 2014-06-25 | 242231260 FS-95d | 188d | 67d | 8/5 M-F w/JLAB Holidays ReBaseline | MECH ENG [120 h] | 8,960.4 |  | ELOUADRHIRI L | 1 | 1 | LATIFA E |  | 11-026 | 12-007 |  | 13-002F |  |  |  |  | 242231262 |  | S |  | 13-015 | PR |  |  | PE |  | 14-001 | ST |
| 242231245 | Two-side glue Counters in Support Arm | 133d | 2014-01-27 | 2014-08-01 | 242231220, 242231215 FS-35d | 133d | 0d | 8/5 M-F w/JLAB Holidays ReBaseline | VISTNG USERS [480 h]; MECH TECH [240 h] | 21,240 |  | ELOUADRHIRI L | 1 | 1 | LATIFA E |  | 11-026 | 12-007 | 12-053 | 13-002F |  | 12-054F |  |  | 242231245 |  | U |  | 13-015 | PR |  |  | PE |  | 14-001 |  |
| 242231250 | Counter-in-rack storage and wrapping | 109d | 2014-01-29 | 2014-07-01 | 242231220 FS-30d, 242231205 FS-66d, 242231145, 242231215, 242231125 FS-183d | 121d | 0d | 8/5 M-F w/JLAB Holidays ReBaseline | SCIENTIST [80 h]; MECH TECH [200 h]; VISTNG USERS [400 h] | 23,714.4 |  | ELOUADRHIRI L | 1 | 1 | LATIFA E |  | 11-026 | 12-007 |  | 13-002F |  |  |  |  | 242231250 |  | U |  | 13-015 | PR |  |  | PE |  | 14-001 |  |
| 242231465 | Soldering the stabilized dividers for H2431 PMTs | 80.5d | 2014-02-21 | 2014-06-16 | 242231460 FS-9d | 242.5d | 0d | 8/5 M-F w/JLAB Holidays ReBaseline | ELEC TECH [100 h]; VISTNG USERS [100 h] | 6,758 |  | ELOUADRHIRI L | 1 | 1 | LATIFA E |  | 11-026 | 12-007 | 12-053 | 13-002F |  |  |  |  | 242231465 |  | S |  | 13-015 | PR |  |  | PE |  | 14-001 | ST |
| 242231430 | Purchase incidentals/tools/material | 67d | 2014-02-25 | 2014-05-29 | 9-140M FS+94d | 337d | 292d | 8/5 M-F w/JLAB Holidays ReBaseline | SUPPLIES & MATERIALS | 19,093.25 |  | ELOUADRHIRI L | 1 | 1 | LATIFA E |  | 11-026 | 12-007 | 12-053 | 13-002F |  |  |  |  | 242231430 |  | D | PE | 13-015 | PR |  |  |  |  | 14-001 |  |
| 242231435 | Purchase/Fabricate/Ship Middle Mag. Disks-2 Procurement | 67d | 2014-02-25 | 2014-05-29 | 9-140M FS+94d | 212d | 79d | 8/5 M-F w/JLAB Holidays ReBaseline | PROCUREMENT<$50K 60 | 10,649.21 |  | ELOUADRHIRI L | 1 | 1 | LATIFA E |  | 11-026 | 12-007 | 12-053 | 13-002F |  |  |  |  | 242231435 |  | U |  | 13-015 | PR |  | PE |  |  | 14-001 |  |
| 242231440 | Purchase/Fabricate/Ship Extern. Mag. Disks-1 Procurement | 67d | 2014-02-25 | 2014-05-29 | 9-140M FS+94d | 212d | 79d | 8/5 M-F w/JLAB Holidays ReBaseline | PROCUREMENT<$50K 60 | 10,649.21 |  | ELOUADRHIRI L | 1 | 1 | LATIFA E |  | 11-026 | 12-007 | 12-053 | 13-002F |  |  |  |  | 242231440 |  | U |  | 13-015 | PR |  | PE |  |  | 14-001 |  |
| 242231445 | Purchase/Fabricate/Ship Extern. Mag. Disks-2 Procurement | 67d | 2014-02-25 | 2014-05-29 | 9-140M FS+94d | 212d | 79d | 8/5 M-F w/JLAB Holidays ReBaseline | PROCUREMENT<$50K 60 | 10,649.21 |  | ELOUADRHIRI L | 1 | 1 | LATIFA E |  | 11-026 | 12-007 | 12-053 | 13-002F |  |  |  |  | 242231445 |  | U |  | 13-015 | PR |  | PE |  |  | 14-001 |  |
| 242231290 | Purchase Coil components and materials | 25d | 2014-02-26 | 2014-04-01 | 242231280, 242231285, 9-130M FS+99d | 206d | 0d | 8/5 M-F w/JLAB Holidays ReBaseline | SUPPLIES & MATERIALS | 11,553.15 | IN | ELOUADRHIRI L | 1 | 1 | LATIFA E | 09-030 | 11-026 | 12-007 |  | 13-002F |  |  |  |  | 242231290 |  | D | PE | 13-015 | PR |  |  |  |  | 14-001 |  |
| 242231305 | Purchase/Fabricate/Ship Inner Mag. Cylinder Procurement | 96d | 2014-03-10 | 2014-07-23 | 242231287 FS+8d, 242231285 FS+8d, 9-130M FS+99d | 192d | 73d | 8/5 M-F w/JLAB Holidays ReBaseline | PROCUREMENT<$50K 60 | 11,392.18 | IN | ELOUADRHIRI L | 1 | 1 | LATIFA E | 09-030 | 11-026 | 12-007 | 12-053 | 13-002F |  |  |  |  | 242231305 |  | D |  | 13-015 | PR |  | PE |  |  | 14-001 |  |
| 242231272 | Counter installation arm - cart and transport rack Engineering Analysis | 74d | 2014-03-20 | 2014-07-02 | 9-140M FS+110d, 242231270 FS-141d | 172d | 0d | 8/5 M-F w/JLAB Holidays ReBaseline | MECH ENG [160 h] | 11,947.2 |  | ELOUADRHIRI L | 1 | 1 | LATIFA E |  | 11-026 | 12-007 |  | 13-002F |  | 12-054F |  |  | 242231272 |  | S |  | 13-015 | PR |  |  | PE |  | 14-001 | ST |
| 242231295 | Fabricate Compensating Coil Machine Shop | 43d | 2014-03-27 | 2014-05-27 | 242231280, 242231290 FS-4d | 268d | 135d | 8/5 M-F w/JLAB Holidays ReBaseline | MSHOP | 8,497.7 | IN | ELOUADRHIRI L | 1 | 1 | LATIFA E | 09-030 | 11-026 | 12-007 | 12-053 | 13-002F |  |  |  |  | 242231295 |  | D | EJ | 13-015 | PR |  |  |  |  | 14-001 |  |
| 242231300 | Fabricate Compensating Coil Procurement | 43d | 2014-03-27 | 2014-05-27 | 242231290 FS-4d, 242231280 FS-110d | 206d | 73d | 8/5 M-F w/JLAB Holidays ReBaseline | PROCUREMENT<$50K 60 | 21,137.44 | IN | ELOUADRHIRI L | 1 | 1 | LATIFA E | 09-030 | 11-026 | 12-007 | 12-053 | 13-002F |  |  |  |  | 242231300 |  | D |  | 13-015 | PR |  | PE |  |  | 14-001 |  |
| 242231390 | Install PMT and check the orientation | 70d | 2014-04-03 | 2014-07-14 | 242231465 FS-51d | 242.5d | 197.5d | 8/5 M-F w/JLAB Holidays ReBaseline | SCIENTIST [40 h]; MECH TECH [80 h] | 6,792.8 | IN | ELOUADRHIRI L | 1 | 1 | LATIFA E | 09-030 | 11-026 | 12-007 |  | 13-002F |  | 12-054 |  |  | 242231390 |  | U |  | 13-015 | PR |  |  | PE |  | 14-001 |  |
| 242231450 | Purchase/Fabricate/Ship Inner Mag. Cylinder #1 | 35d | 2014-04-10 | 2014-05-29 | 9-140M FS+126d | 212d | 79d | 8/5 M-F w/JLAB Holidays ReBaseline | PROCUREMENT<$50K 60 | 11,392.18 |  | ELOUADRHIRI L | 1 | 1 | LATIFA E |  | 11-026 | 12-007 | 12-053 | 13-002F |  |  |  |  | 242231450 |  | U |  | 13-015 | PR |  | PE |  |  | 14-001 |  |
| 242231455 | Purchase/Fabricate/Ship Inner Non-mag. Cylinder #2 | 35d | 2014-04-10 | 2014-05-29 | 9-140M FS+126d | 212d | 79d | 8/5 M-F w/JLAB Holidays ReBaseline | PROCUREMENT<$50K 60 | 11,392.18 |  | ELOUADRHIRI L | 1 | 1 | LATIFA E |  | 11-026 | 12-007 | 12-053 | 13-002F |  |  |  |  | 242231455 |  | U |  | 13-015 | PR |  | PE |  |  | 14-001 |  |
| 242231255 | Transmittance test of assembled Counters in Rack | 120d | 2014-06-04 | 2014-11-20 | 242231250 FS-20d, 242231215, 242231220, 242231125 FS-183d | 121d | 76d | 8/5 M-F w/JLAB Holidays ReBaseline | MECH TECH [80 h]; VISTNG USERS [120 h]; SCIENTIST [80 h] | 12,270.8 |  | ELOUADRHIRI L | 1 | 1 | LATIFA E |  | 11-026 | 12-007 |  | 13-002F |  |  |  |  | 242231255 |  | S |  | 13-015 | PR |  |  | PE |  | 14-001 | ST |
| 242231275 | CTOF procure installation tooling and transport rack | 111d | 2014-08-15 | 2015-02-03 | 242231270 FS-38d, 242231272 FS+30d | 172d | 127d | 8/5 M-F w/JLAB Holidays ReBaseline | PROCUREMENT<$50K 60 NO ESCALATION FY15 | 11,352.96 |  | ELOUADRHIRI L | 1 | 1 | LATIFA E |  | 11-026 | 12-007 | 12-053 | 13-002F |  | 12-054 |  |  | 242231275 |  | D |  | 13-015 | PR |  | PE |  |  | 14-001 |  |
| 242231395 | Install shield disks onto the Light guides | 70d | 2014-09-09 | 2014-12-17 | 242231285 FS-110d, 242231440 FS-9d, 242231305 FS-41d, 242231245 FS+25d, 242231435 FS-9d, 242231445 FS-9d, 9-130M FS+99d | 133d | 88d | 8/5 M-F w/JLAB Holidays ReBaseline | SCIENTIST [80 h]; MECH TECH [104 h] | 10,935.68 | IN | ELOUADRHIRI L | 1 | 1 | LATIFA E | 09-030 | 11-026 | 12-007 |  | 13-002F |  | 12-054 |  |  | 242231395 |  | U |  | 13-015 | PR |  |  | PE |  | 14-001 |  |
| 242231400 | Install compensation coils and check polarity | 70d | 2014-09-09 | 2014-12-17 | 242231460 FS-9d, 242231300 FS-1d, 242231450 FS-9d, 242231455 FS-9d, 242231295 FS-63d, 242231245 FS+25d | 133d | 88d | 8/5 M-F w/JLAB Holidays ReBaseline | SCIENTIST [96 h]; MECH TECH [96 h] | 11,760 | IN | ELOUADRHIRI L | 1 | 1 | LATIFA E | 09-030 | 11-026 | 12-007 |  | 13-002F |  | 12-054 |  |  | 242231400 |  | U |  | 13-015 | PR |  |  | PE |  | 14-001 |  |
| 242231405 | Install Middle. Mag. Shields onto PMT | 70d | 2014-09-09 | 2014-12-17 | 242231245 FS+25d, 9-130M FS+99d, 242231285 FS-110d, 242231305 FS-41d | 133d | 88d | 8/5 M-F w/JLAB Holidays ReBaseline | SCIENTIST [192 h]; MECH TECH [192 h] | 23,520 | IN | ELOUADRHIRI L | 1 | 1 | LATIFA E | 09-030 | 11-026 | 12-007 |  | 13-002F |  | 12-054 |  |  | 242231405 |  | U |  | 13-015 | PR |  |  | PE |  | 14-001 |  |
| 242231325 | Assemble the Setup for Magnetic Shields Tests | 63d | 2014-09-18 | 2014-12-17 | 242231320 FS-68d | 172d | 0d | 8/5 M-F w/JLAB Holidays ReBaseline | MECH ENG [80 h]; MECH TECH [120 h]; VISTNG USERS [120 h]; SCIENTIST [80 h] | 20,137.2 | IN | ELOUADRHIRI L | 1 | 1 | LATIFA E | 09-030 | 11-026 | 12-007 |  | 13-002F | 12-027 | 12-054F |  |  | 242231325 |  | S |  | 13-015 | PR |  |  | PE |  | 14-001 | ST |
| 242231320 | Purchase DCPS 6030A 200V/17A Ext.Magn. Shield | 67d | 2014-09-19 | 2015-01-05 | 9-140M FS+239d | 172d | 0d | 8/5 M-F w/JLAB Holidays ReBaseline | PROCUREMENT<$50K 60 NO ESCALATION FY15 | 32,362.45 | IN | ELOUADRHIRI L | 1 | 1 | LATIFA E | 09-030 | 11-026 | 12-007 |  | 13-002F | 12-027 | 12-054F |  |  | 242231320 |  | U |  | 13-015 | PR |  | PE |  |  | 14-001 |  |
| 242231265 | CTOF procure support and solenoid harness and interface rings | 110d | 2014-10-01 | 2015-03-18 | 9-155M, 242231260, 242231262 | 121d | 76d | 8/5 M-F w/JLAB Holidays ReBaseline | PROCUREMENT<$50K 60 | 45,478.93 |  | ELOUADRHIRI L | 1 | 1 | LATIFA E |  | 11-026 | 12-007 | 12-053 | 13-002F |  |  |  |  | 242231265 |  | D |  | 13-015 | PR |  | PE |  |  | 14-001 |  |
| 242231335 | Purchase Cables and Connectors | 41d | 2014-10-06 | 2014-12-03 | 9-155M FS+3d | 45d | 0d | 8/5 M-F w/JLAB Holidays ReBaseline | SCIENTIST [24 h]; PROCUREMENT<$50K 60 | 47,835.32 | IN | ELOUADRHIRI L | 1 | 1 | LATIFA E | 09-030 | 11-026 | 12-007 |  | 13-002F |  |  |  |  | 242231335 |  | D |  | 13-015 | PR |  | CP | PE |  | 14-001 |  |
| 242231345 | Final Drawings of Patch Panels for LV & HV;200 ch | 9d | 2014-10-06 | 2014-10-16 | 9-155M FS+3d | 81d | 0d | 8/5 M-F w/JLAB Holidays ReBaseline | MECH DES [80 h] | 4,104 | IN | ELOUADRHIRI L | 1 | 1 | LATIFA E | 09-030 | 11-026 | 12-007 |  | 13-002F |  |  |  |  | 242231345 |  | H |  | 13-015 | PR |  |  | PE |  | 14-001 |  |
| 242231350 | Final Drawings of Splitter to TDC and ADC; 100 ch | 42d | 2014-10-17 | 2014-12-17 | 242231345 | 81d | 0d | 8/5 M-F w/JLAB Holidays ReBaseline | MECH DES [80 h] | 4,104 | IN | ELOUADRHIRI L | 1 | 1 | LATIFA E | 09-030 | 11-026 | 12-007 |  | 13-002F |  |  |  |  | 242231350 |  | H |  | 13-015 | PR |  |  | PE |  | 14-001 |  |
| 242231355 | Fabricate Patch Panels for LV&HV | 84d | 2014-10-17 | 2015-02-26 | 242231345 | 81d | 0d | 8/5 M-F w/JLAB Holidays ReBaseline | MECH TECH [120 h]; SCIENTIST [40 h]; VISTNG USERS [40 h]; ELEC TECH [120 h] | 15,148 | IN | ELOUADRHIRI L | 1 | 1 | LATIFA E | 09-030 | 11-026 | 12-007 | 12-053 | 13-002F |  |  |  |  | 242231355 |  | U |  | 13-015 | PR |  |  | PE |  | 14-001 |  |
| 242231340 | Fabricate Cables LV&HV | 82d | 2014-11-07 | 2015-03-17 | 242231335 FS-17d | 45d | 0d | 8/5 M-F w/JLAB Holidays ReBaseline | MECH TECH [200 h]; SCIENTIST [40 h]; VISTNG USERS [40 h] | 13,294.8 | IN | ELOUADRHIRI L | 1 | 1 | LATIFA E | 09-030 | 11-026 | 12-007 | 12-053 | 13-002F |  |  |  |  | 242231340 |  | U |  | 13-015 | PR |  |  | PE |  | 14-001 |  |
| 242231360 | Fabricate Splitter Parts | 33d | 2014-12-17 | 2015-02-12 | 242231350 FS-1d, 242231345 FS-1d | 81d | 0d | 8/5 M-F w/JLAB Holidays ReBaseline | ELEC TECH [40 h]; SCIENTIST [40 h]; MECH TECH [80 h] | 8,672.4 | IN | ELOUADRHIRI L | 1 | 1 | LATIFA E | 09-030 | 11-026 | 12-007 | 12-053 | 13-002F |  |  |  |  | 242231360 |  | H |  | 13-015 | PR |  |  | PE |  | 14-001 |  |

Notes:
- 242231260: Steps: Complete drawings of CTOF support; Complete drawings of CTOF solenoid harness
- 242231270: Steps: Complete drawing package for cart system; Complete drawing package for transport rack
- 242231145: Steps: Complete design for tooling; Complete testing phase; Complete fabrication
- 242231285: Steps: Complete drawings for compensation coil and bayonet connector; Complete drawings for end-cap cones; Complete drawings for inner shield
- 242231262: Steps: Deformation calculation; Stress analysis
- 242231465: Steps: Purchase 130 PCB boards with components; Dismount PMT shields; Solder PCB board to the PMT base; Mount PMT shield
- 242231272: Steps: Fabrication of installation arm cart; Fabrication of CTOF counter transportation rack
- 242231255: Steps: Test of rack 1; Test of rack 2; Test of rack 3; Test of rack 4; Test of rack 5; Test of rack 6
- 242231325: Steps: Install and power SC solenoid; Install support for the magnetic shield; Install magnetic sensors

| ID | WBS | Activity | Type | Duration | Start | Finish | Predecessors | Total float | Free float | Calendar | Resources | Cost | Original Activity ID Rebaseline | PHAS - Project Phase | RESP - Responsibility | STRT%COMP for CM EVM | FNSH%COMP for CM EVM | EVMS Reporting Codes | CAM RESPONSIBLE | CR 09-030 Repair | CR 11-026 | CR 12-007 | CR 12-027 | CR 12-054 | CR 13-002 | BOE Labor | CR 13-015 | Post Rebaseline | CR 14-001 | CR 12-053 | Activities with Steps | CR 10-017 | CR 11-021 | CR 11-035 | Advance Purchase Plan > 500K | CR 08-045 | CR 11-001 | CR 11-032 | CR 11-009 | CR 12-001 | CR 11-056 |
| --- | --- | --- | --- | --- | --- | --- | --- | --- | --- | --- | --- | --- | --- | --- | --- | --- | --- | --- | --- | --- | --- | --- | --- | --- | --- | --- | --- | --- | --- | --- | --- | --- | --- | --- | --- | --- | --- | --- | --- | --- | --- |
| 242231385 |  | Testing External magnetic shields |  | 25d | 2014-12-18 | 2015-02-03 | 242231285 FS-120d, 242231325, 9-130M FS+89d | 172d | 127d | 8/5 M-F w/JLAB Holidays ReBaseline | SCIENTIST [192 h]; MECH TECH [192 h] | 23,520 | 242231385 | IN | ELOUADRHIRI L | 1 | 1 | U | LATIFA E | 09-030 | 11-026 | 12-007 | 12-027 | 12-054 | 13-002F | PE | 13-015 | PR | 14-001 |  |  |  |  |  |  |  |  |  |  |  |  |
| 242231370 |  | Assembling of the CTOF splitters |  | 40d | 2015-02-13 | 2015-04-09 | 242231360 | 81d | 36d | 8/5 M-F w/JLAB Holidays ReBaseline | ELEC TECH [80 h]; VISTNG USERS [80 h]; SCIENTIST [80 h] | 11,420.8 | 242231370 | IN | ELOUADRHIRI L | 1 | 1 | U | LATIFA E | 09-030 | 11-026 | 12-007 |  |  | 13-002F | PE | 13-015 | PR | 14-001 |  |  |  |  |  |  |  |  |  |  |  |  |
| 242231365 |  | Assembling of the CTOF patch panels |  | 30d | 2015-02-27 | 2015-04-09 | 242231355 | 81d | 36d | 8/5 M-F w/JLAB Holidays ReBaseline | ELEC TECH [80 h]; VISTNG USERS [80 h]; SCIENTIST [40 h] | 8,413.6 | 242231365 | IN | ELOUADRHIRI L | 1 | 1 | U | LATIFA E | 09-030 | 11-026 | 12-007 |  |  | 13-002F | PE | 13-015 | PR | 14-001 |  |  |  |  |  |  |  |  |  |  |  |  |
| 242231410 |  | CTOF in Storage Rack cabling |  | 33d | 2015-03-18 | 2015-05-01 | 242231285 FS-100d, 9-130M FS+109d, 242231340, 242231335 FS-10d, 242231245, 242231305 FS+10d | 45d | 0d | 8/5 M-F w/JLAB Holidays ReBaseline | SCIENTIST [80 h]; MECH TECH [40 h] | 7,907.2 | 242231410 | IN | ELOUADRHIRI L | 1 | 1 | U | LATIFA E | 09-030 | 11-026 | 12-007 |  | 12-054 | 13-002F | PE | 13-015 | PR | 14-001 |  |  |  |  |  |  |  |  |  |  |  |  |
| 242231415 |  | Assemble the DAQ system |  | 25d | 2015-03-30 | 2015-05-01 | 242231410 FS-25d | 45d | 0d | 8/5 M-F w/JLAB Holidays ReBaseline | SCIENTIST [96 h] | 7,217.28 | 242231415 | IN | ELOUADRHIRI L | 1 | 1 | H | LATIFA E | 09-030 | 11-026 | 12-007 |  |  | 13-002F | PE | 13-015 | PR | 14-001 | 12-053 |  |  |  |  |  |  |  |  |  |  |  |
| 242231420 |  | Standalone CTOF testing/optimizing |  | 29d | 2015-05-04 | 2015-06-15 | 242231370 FS-20d, 242231410, 242231415, 242231245 FS+29d, 242231255 FS+29d, 242231405, 242231120 FS-65d, 242231365 FS-20d, 242231395, 242231400, 242231250, 242231115 FS-65d, 242231200, 242231390 | 45d | 0d | 8/5 M-F w/JLAB Holidays ReBaseline | SCIENTIST [64 h]; MECH TECH [12 h] | 5,379.36 | 242231420 |  | ELOUADRHIRI L | 1 | 1 | H | LATIFA E |  | 11-026 | 12-007 |  | 12-054 | 13-002F | PE | 13-015 | PR | 14-001 |  |  |  |  |  |  |  |  |  |  |  |  |
| 242231425 |  | Prepare CTOF-in-Storage-Rack for transportation |  | 35d | 2015-06-16 | 2015-08-04 | 242231265 FS-15d, 242231420, 242231275 FS-35d, 242231385 FS-35d | 45d | 0d | 8/5 M-F w/JLAB Holidays ReBaseline | VISTNG USERS [120 h]; MECH TECH [120 h]; SCIENTIST [120 h] | 17,170.8 | 242231425 |  | ELOUADRHIRI L | 1 | 1 | S | LATIFA E |  | 11-026 | 12-007 | 12-027 | 12-054 | 13-002F | PE | 13-015 | PR | 14-001 |  | ST |  |  |  |  |  |  |  |  |  |  |
| 242231470M |  | CTOF Ready for Installation | milestone | 0d | 2015-08-04 | 2015-08-04 | 242231430, 242231425, 242231013E | 45d | 0d | 8/5 M-F w/JLAB Holidays ReBaseline |  |  | 242231470M |  | ELOUADRHIRI L | 1 | 1 | M | LATIFA E |  | 11-026 | 12-007 | 12-027 | 12-054 | 13-002F |  | 13-015 | PR |  |  |  |  |  |  |  |  |  |  |  |  |  |
|  | 2 | **1.4.2.2.3.2 FORWARD TOF** |  |  | 2009-10-01 | 2014-03-31 |  |  |  |  |  |  |  |  |  |  |  |  |  |  |  |  |  |  |  |  |  |  |  |  |  |  |  |  |  |  |  |  |  |  |  |
| 142232005 |  | FTOF-P-#1 Prcrmnt of Scintillator Matrl & Light Guides |  | 60d | 2009-10-01 | 2010-01-04 | 12222060, 9-100M, 1222232030, 12222065 | 806d | 0d |  |  |  |  |  | ELOUADRHIRI L | 1 | 1 |  | LATIFA E |  | 11-026 |  |  |  | 13-002F |  |  |  |  |  |  | 10-017 | 11-021 | 11 -035 |  |  |  |  |  |  |  |
| 142232010 |  | FTOF-P-#1 Prcrmnt of PMTs & Hi Voltage Dividers |  | 60d | 2009-10-01 | 2010-01-04 | 12222070, 9-100M | 931d |  |  |  |  |  |  | ELOUADRHIRI L | 1 | 1 |  | LATIFA E |  | 11-026 |  |  |  | 13-002F |  |  |  |  |  |  | 10-017 | 11-021 | 11 -035 |  |  |  |  |  |  |  |
| 142232015 |  | FTOF-P-#1 Vend Fab of Scintillator Matrl & Light Guides Original Labor |  | 125d | 2010-01-05 | 2010-07-01 | 142232005 | 806d |  |  | SCIENTIST [80 h] | 5,304.8 |  |  | ELOUADRHIRI L | 1 | 1 |  | LATIFA E |  | 11-026 |  |  |  | 13-002F |  |  |  |  |  |  | 10-017 | 11-021 | 11 -035 | APP | 08-045 |  |  |  |  |  |
| 142232025 |  | FTOF - P#1 QA of Scintillators and PMTs (Original Labor) |  | 20d | 2010-05-03 | 2010-05-28 | 9-100M FS+142d | 829d |  |  | VISTNG USERS [40 h]; PD UNIV STUDNT [13.33 h]; MECH DES [1.35 h]; ELEC TECH [4 h]; MECH TECH [14.65 h]; SCIENTIST [8 h] | 2,228.41 |  |  | ELOUADRHIRI L | 1 | 1 |  | LATIFA E |  | 11-026 |  |  |  | 13-002F |  |  |  |  |  |  | 10-017 | 11-021 | 11 -035 |  |  |  |  |  |  |  |
| 142232160 |  | Final Drawings |  | 10d | 2010-06-01 | 2010-06-14 | 9-100M FS+162d | 20d | 0d |  | SCIENTIST [152 h]; MECH ENG [152 h] | 20,088.32 |  |  | ELOUADRHIRI L | 1 | 1 |  | LATIFA E |  | 11-026 |  |  | 12-054F | 13-002F |  |  |  |  |  |  | 10-017 | 11-021 | 11 -035 |  |  |  |  |  |  |  |
| 142232165 |  | FTOF Travel FY10 |  | 86d | 2010-06-01 | 2010-09-30 | 9-100M FS+162d | 20d | 0d |  | TRAVEL | 2,000 |  |  | ELOUADRHIRI L | 1 | 1 |  | LATIFA E |  | 11-026 |  |  |  | 13-002F |  |  |  |  |  |  | 10-017 | 11-021 | 11 -035 |  |  |  |  |  |  |  |
| 142232200M |  | FTOF Construction Milestone | milestone | 0d | 2010-06-01 | 2010-06-01 | 142232160 FS-10d, 9-100M FS+162d | 20d | 0d |  |  |  |  |  | ELOUADRHIRI L | 1 | 1 |  | LATIFA E |  | 11-026 |  |  | 12-054F | 13-002F |  |  |  |  |  |  | 10-017 | 11-021 | 11 -035 |  |  |  |  |  |  |  |
| 142232205 |  | PMT /Divider Procurement Prep FY10 |  | 86d | 2010-06-01 | 2010-09-30 | 142232200M | 248d | 0d |  | SCIENTIST [63.7 h] | 4,223.95 |  |  | ELOUADRHIRI L | 1 | 1 |  | LATIFA E |  | 11-026 | 12-007 |  |  | 13-002F |  |  |  |  |  |  | 10-017 | 11-021 | 11 -035 |  |  | 11-001 |  |  |  |  |
| 142232310 |  | Preparation of USC construction contract |  | 86d | 2010-06-01 | 2010-09-30 | 142232200M | 20d | 0d |  |  |  |  |  | ELOUADRHIRI L | 1 | 1 |  | LATIFA E |  | 11-026 |  |  |  | 13-002F |  |  |  |  |  |  | 10-017 |  | 11 -035 |  |  |  |  |  |  |  |
| 142232330 |  | Complete design of panel-1b support FY10 |  | 86d | 2010-06-01 | 2010-09-30 | 142232200M | 722d | 0d |  | MECH DES [141.83 h]; MECH ENG [70.91 h] | 11,085.81 |  |  | ELOUADRHIRI L | 1 | 1 |  | LATIFA E |  | 11-026 |  |  |  | 13-002F |  |  |  |  |  |  | 10-017 | 11-021 | 11 -035 |  |  | 11-001 |  |  |  |  |
| 142232340 |  | Finalize panel-1b scintillator lengths |  | 64d | 2010-06-01 | 2010-08-30 | 142232200M | 840d | 528d |  | MECH ENG [40 h]; MECH DES [80 h] | 6,253.2 |  |  | ELOUADRHIRI L | 1 | 1 |  | LATIFA E |  | 11-026 |  |  |  | 13-002F |  |  |  |  |  |  | 10-017 | 11-021 | 11 -035 |  |  |  | 11-032 |  |  |  |
| 142232365 |  | PMT Study Procurement |  | 86d | 2010-06-01 | 2010-09-30 | 142232200M | 685d | 0d |  | PROCUREMENT<$50K 60 | 10,000 |  |  | ELOUADRHIRI L | 1 | 1 |  | LATIFA E |  | 11-026 |  |  |  | 13-002F |  |  |  |  |  |  | 10-017 | 11-021 | 11 -035 |  |  |  |  |  |  |  |
| 142232370 |  | PMT Studies at JLAB FY10 |  | 86d | 2010-06-01 | 2010-09-30 | 142232365 FS-86d | 685d | 0d |  | SCIENTIST [143.33 h] | 9,504.21 |  |  | ELOUADRHIRI L | 1 | 1 |  | LATIFA E |  | 11-026 |  |  |  | 13-002F |  |  |  |  |  |  | 10-017 | 11-021 | 11 -035 |  |  | 11-001 |  |  |  |  |
| 142232230 |  | Scintillator Procurement Prep - Labor FY10 |  | 64d | 2010-07-01 | 2010-09-30 | 142232200M FS+22d | 312d | 0d |  | SCIENTIST [29.77 h] | 1,974.05 |  |  | ELOUADRHIRI L | 1 | 1 |  | LATIFA E |  | 11-026 |  |  |  | 13-002F |  |  |  |  |  |  | 10-017 | 11-021 | 11 -035 |  |  | 11-001 | 11-032 |  |  |  |
| 142232350 |  | Complete panel-1b manufacturing drawings |  | 32d | 2010-08-02 | 2010-09-15 | 9-100M FS+205d | 207d | 0d |  | MECH ENG [80 h]; MECH DES [160 h] | 12,506.4 |  |  | ELOUADRHIRI L | 1 | 1 |  | LATIFA E |  | 11-026 | 12-007 |  | 12-054F | 13-002F |  |  |  |  |  |  | 10-017 | 11-021 | 11 -035 |  |  |  | 11-032 |  |  |  |
| 142232270 |  | Backing Support Procurement Prep - Labor FY10 |  | 21d | 2010-09-01 | 2010-09-30 | 142232200M FS+65d | 189d | 0d |  | SCIENTIST [22.7 h] | 1,505.24 |  |  | ELOUADRHIRI L | 1 | 1 |  | LATIFA E |  | 11-026 |  |  |  | 13-002F |  |  |  |  |  |  | 10-017 | 11-021 | 11 -035 |  |  | 11-001 | 11-032 |  |  |  |
| 142232170 |  | FTOF Travel FY11 |  | 248d | 2010-10-01 | 2011-09-30 | 142232165 | 20d | 0d |  | TRAVEL | 4,127.6 |  |  | ELOUADRHIRI L | 1 | 1 |  | LATIFA E |  | 11-026 |  |  |  | 13-002F |  |  |  |  |  |  | 10-017 | 11-021 | 11 -035 |  |  |  |  |  |  |  |
| 142232205a |  | PMT /Divider Procurement Prep FY11 |  | 22d | 2010-10-01 | 2010-11-01 | 142232205 | 248d | 0d |  | SCIENTIST [16.3 h] | 1,115.41 |  |  | ELOUADRHIRI L | 1 | 1 |  | LATIFA E |  | 11-026 | 12-007 |  |  | 13-002F |  |  |  |  |  |  | 10-017 | 11-021 | 11 -035 |  |  | 11-001 |  |  |  |  |
| 142232230a |  | Scintillator Procurement Prep - Labor FY11 |  | 22d | 2010-10-01 | 2010-11-01 | 142232230 | 312d | 0d |  | SCIENTIST [10.23 h] | 700.04 |  |  | ELOUADRHIRI L | 1 | 1 |  | LATIFA E |  | 11-026 |  |  |  | 13-002F |  |  |  |  |  |  | 10-017 | 11-021 | 11 -035 |  |  | 11-001 | 11-032 |  |  |  |
| 142232270a |  | Backing Support Procurement Prep - Labor FY11 |  | 16d | 2010-10-01 | 2010-10-22 | 142232270 | 189d | 0d |  | SCIENTIST [17.3 h] | 1,183.84 |  |  | ELOUADRHIRI L | 1 | 1 |  | LATIFA E |  | 11-026 |  |  |  | 13-002F |  |  |  |  |  |  | 10-017 | 11-021 | 11 -035 |  |  | 11-001 | 11-032 |  |  |  |
| 142232330a |  | Complete design of panel-1b support FY11 |  | 21d | 2010-10-01 | 2010-10-29 | 142232330 | 722d |  |  | MECH DES [18.17 h]; MECH ENG [9.09 h] | 1,465.85 |  |  | ELOUADRHIRI L | 1 | 1 |  | LATIFA E |  | 11-026 |  |  |  | 13-002F |  |  |  |  |  |  | 10-017 | 11-021 | 11 -035 |  |  | 11-001 |  |  |  |  |
| 142232370a |  | PMT Studies at JLAB FY11 |  | 58d | 2010-10-01 | 2010-12-30 | 142232370 | 685d |  |  | SCIENTIST [96.67 h] | 6,615.13 |  |  | ELOUADRHIRI L | 1 | 1 |  | LATIFA E |  | 11-026 |  |  |  | 13-002F |  |  |  |  |  |  | 10-017 | 11-021 | 11 -035 |  |  | 11-001 |  |  |  |  |
| 142232220 |  | Vend Fab PMT /Divider Peg Point #1 First Articles (Qty. 6) |  | 37d | 2010-12-01 | 2011-01-31 | 142232205a FS+19d | 248d | 0d |  | PROCUREMENT<$50K 60 NO ESCALATION | 4,968 |  |  | ELOUADRHIRI L | 1 | 1 |  | LATIFA E |  | 11-026 |  |  |  | 13-002F |  |  |  |  |  |  | 10-017 | 11-021 | 11 -035 |  |  |  |  | 11-009 |  |  |
| 142232221 |  | Vend Fab PMT /Divider Peg Point #2 Production Delivery #1 (Qty. 133) |  | 163d | 2010-12-01 | 2011-07-29 | 142232220 FS-37d | 248d | 0d |  | PROCUREMENT>$50K 69 NO ESCALATION; PROCUREMENT<$50K 60 NO ESCALATION | 110,124 |  |  | ELOUADRHIRI L | 1 | 1 |  | LATIFA E |  | 11-026 |  |  |  | 13-002F |  |  |  |  |  |  | 10-017 | 11-021 | 11 -035 |  |  |  |  | 11-009 |  |  |
| 142232222 |  | Vend Fab PMT /Divider Peg Point #3 Production Delivery #2 (Qty. 133) |  | 228d | 2010-12-01 | 2011-10-31 | 142232221 FS-163d | 248d | 0d |  | PROCUREMENT>$50K 69 NO ESCALATION | 110,124 |  |  | ELOUADRHIRI L | 1 | 1 |  | LATIFA E |  | 11-026 |  |  |  | 13-002F |  |  |  |  |  |  | 10-017 | 11-021 | 11 -035 |  |  |  |  | 11-009 |  |  |
| 142232223 |  | Vend Fab PMT /Divider Peg Point #4 Production Delivery #3 (Qty. 134) |  | 265d | 2010-12-01 | 2011-12-30 | 142232222 FS-228d | 248d | 0d |  | PROCUREMENT>$50K 69 NO ESCALATION | 110,952 |  |  | ELOUADRHIRI L | 1 | 1 |  | LATIFA E |  | 11-026 |  |  |  | 13-002F |  |  |  |  |  |  | 10-017 | 11-021 | 11 -035 |  |  |  |  | 11-009 |  |  |
| 142232355 |  | Complete Design of Panel-1a Frame Modification Pieces |  | 103d | 2011-01-04 | 2011-05-31 | 142232200M FS+145d | 39d | 0d |  | MECH ENG [40 h]; MECH DES [80 h] | 6,452.4 |  |  | ELOUADRHIRI L | 1 | 1 |  | LATIFA E |  | 11-026 | 12-007 |  |  | 13-002F |  |  |  |  |  |  | 10-017 | 11-021 | 11 -035 |  |  |  | 11-032 |  |  |  |
| 142232315M |  | Award USC Contract | milestone | 0d | 2011-04-01 | 2011-04-01 | 142232310 FS+120d | 20d | 0d |  |  |  |  |  | ELOUADRHIRI L | 1 | 1 |  | LATIFA E |  | 11-026 |  |  |  | 13-002F |  |  |  |  |  |  | 10-017 | 11-021 | 11 -035 |  |  |  |  |  |  |  |
| 142232320 |  | Peg Point #1 - Set up Assembly Space at USC |  | 21d | 2011-04-01 | 2011-04-29 | 142232315M | 20d | 0d |  | PROCUREMENT<$50K 60 NO ESCALATION | 35,617.37 |  |  | ELOUADRHIRI L | 1 | 1 |  | LATIFA E |  | 11-026 |  |  |  | 13-002F |  |  |  |  |  |  | 10-017 | 11-021 | 11 -035 |  |  |  |  |  |  |  |
| 142232320A |  | Peg Point #2 - Readiness review at USC |  | 21d | 2011-04-01 | 2011-04-29 | 142232320 FS-21d | 20d | 0d |  | PROCUREMENT<$50K 60 NO ESCALATION | 8,321.9 |  |  | ELOUADRHIRI L | 1 | 1 |  | LATIFA E |  | 11-026 |  |  |  | 13-002F |  |  |  |  |  |  | 10-017 | 11-021 | 11 -035 |  |  |  |  |  |  |  |
| 142232320B |  | Peg Point #3 - PMT/divider testing start |  | 21d | 2011-04-01 | 2011-04-29 | 142232320A FS-21d | 20d | 0d |  | PROCUREMENT<$50K 60 NO ESCALATION | 2,164.22 |  |  | ELOUADRHIRI L | 1 | 1 |  | LATIFA E |  | 11-026 |  |  |  | 13-002F |  |  |  |  |  |  | 10-017 | 11-021 | 11 -035 |  |  |  |  |  |  |  |
| 142232320C |  | Peg Point #4 - Scintillator testing start |  | 42d | 2011-04-01 | 2011-05-31 | 142232320B FS-21d | 20d | 0d |  | PROCUREMENT<$50K 60 NO ESCALATION; PROCUREMENT>$50K 69 NO ESCALATION | 21,878.08 |  |  | ELOUADRHIRI L | 1 | 1 |  | LATIFA E |  | 11-026 |  |  |  | 13-002F |  |  |  |  |  |  | 10-017 | 11-021 | 11 -035 |  |  |  |  |  |  |  |
| 142232320D |  | Peg Point #5 - Phase 1 assembly start (first 5units) |  | 169d | 2011-04-01 | 2011-11-30 | 142232320C FS-42d | 20d | 0d |  | PROCUREMENT>$50K 69 NO ESCALATION | 64,435.89 |  |  | ELOUADRHIRI L | 1 | 1 |  | LATIFA E |  | 11-026 |  |  |  | 13-002F |  |  |  |  |  |  | 10-017 | 11-021 | 11 -035 |  |  |  |  |  |  |  |
| 142232320F |  | Peg Point #6A - Phase 2 assembly start (next 42 units) Part 1 |  | 206d | 2011-04-01 | 2012-01-31 | 142232320D FS-169d | 20d | 0d |  | PROCUREMENT>$50K 69 NO ESCALATION | 25,215.57 |  |  | ELOUADRHIRI L | 1 | 1 |  | LATIFA E |  | 11-026 |  |  |  | 13-002F |  |  |  |  |  |  | 10-017 | 11-021 | 11 -035 |  |  |  |  |  |  |  |
| 142232240 |  | Phase 1a FRT (BC-404) first article (3 ea) |  | 33d | 2011-04-14 | 2011-05-31 | 142232340 FS-377d, 142232230a FS+107d | 312d | 0d |  | PROCUREMENT<$50K 60 NO ESCALATION | 3,096 |  |  | ELOUADRHIRI L | 1 | 1 |  | LATIFA E |  | 11-026 |  |  |  | 13-002F |  |  |  |  |  |  | 10-017 | 11-021 | 11 -035 |  |  |  | 11-032 |  |  |  |
| 142232241 |  | Phase 1b LAL (BC-408) first article (3 ea) |  | 33d | 2011-04-14 | 2011-05-31 | 142232240 FS-33d | 312d | 0d |  | PROCUREMENT<$50K 60 NO ESCALATION | 2,508 |  |  | ELOUADRHIRI L | 1 | 1 |  | LATIFA E |  | 11-026 |  |  |  | 13-002F |  |  |  |  |  |  | 10-017 | 11-021 | 11 -035 |  |  |  | 11-032 |  |  |  |
| 142232242 |  | Phase 1c FRT (BC-404) 72 bars |  | 98d | 2011-04-14 | 2011-08-31 | 142232241 FS-33d | 312d | 0d |  | PROCUREMENT<$50K 60 NO ESCALATION | 29,971.44 |  |  | ELOUADRHIRI L | 1 | 1 |  | LATIFA E |  | 11-026 |  |  |  | 13-002F |  |  |  |  |  |  | 10-017 | 11-021 | 11 -035 |  |  |  | 11-032 |  |  |  |
| 142232243 |  | Phase 1d FRT (BC-404) 90 bars |  | 140d | 2011-04-14 | 2011-10-31 | 142232242 FS-98d | 312d | 0d |  | PROCUREMENT<$50K 60 NO ESCALATION; PROCUREMENT>$50K 69 NO ESCALATION | 37,464.3 |  |  | ELOUADRHIRI L | 1 | 1 |  | LATIFA E |  | 11-026 |  |  |  | 13-002F |  |  |  |  |  |  | 10-017 | 11-021 | 11 -035 |  |  |  | 11-032 |  |  |  |
| 142232244 |  | Phase 1e FRT (BC-404) 24 bars |  | 177d | 2011-04-14 | 2011-12-30 | 142232243 FS-140d | 312d | 0d |  | PROCUREMENT>$50K 69 NO ESCALATION | 9,990.48 |  |  | ELOUADRHIRI L | 1 | 1 |  | LATIFA E |  | 11-026 |  |  |  | 13-002F |  |  |  |  |  |  | 10-017 | 11-021 | 11 -035 |  |  |  | 11-032 |  |  |  |
| 142232280 |  | Backing Support Phase 1 Delivery |  | 290d | 2011-05-02 | 2012-06-29 | 142232270a FS+125d | 189d | 0d |  | PROCUREMENT<$50K 60 NO ESCALATION FY12; PROCUREMENT>$50K 69 NO ESCALATION FY12 | 75,114 |  |  | ELOUADRHIRI L | 1 | 1 |  | LATIFA E |  | 11-026 |  |  |  | 13-002F |  |  |  |  |  |  | 10-017 | 11-021 | 11 -035 |  |  |  | 11-032 |  |  |  |
| 142232356 |  | Final Panel 1-1/1-b manufacturing support FY11 |  | 101d | 2011-05-10 | 2011-09-30 | 142232355 FS-15d | 39d | 0d |  | MECH ENG [98.79 h]; MECH DES [237.1 h] | 17,780.61 |  |  | ELOUADRHIRI L | 1 | 1 |  | LATIFA E |  | 11-026 | 12-007 |  |  | 13-002F |  |  |  |  |  |  | 10-017 | 11-021 | 11 -035 |  |  |  | 11-032 |  | 12-001 |  |
| 142232352 |  | Panel 1-a/1-b Installation tooling labor |  | 10d | 2011-06-01 | 2011-06-14 | 142232350 FS+173d | 207d | 0d |  | MECH ENG [20 h]; MECH DES [40 h] | 3,226.2 |  |  | ELOUADRHIRI L | 1 | 1 |  | LATIFA E |  | 11-026 | 12-007 |  | 12-054F | 13-002F |  |  |  |  |  |  | 10-017 | 11-021 | 11 -035 |  |  |  | 11-032 |  |  |  |
| 142232353 |  | Panel 1-a/1-b Installation tooling Proc |  | 22d | 2011-06-01 | 2011-06-30 | 142232352 FS-10d | 207d | 184d |  | PROCUREMENT<$50K 60 | 5,000 |  |  | ELOUADRHIRI L | 1 | 1 |  | LATIFA E |  | 11-026 | 12-007 |  | 12-054F | 13-002F |  |  |  |  |  |  | 10-017 | 11-021 | 11 -035 |  |  |  | 11-032 |  |  |  |
| 142232281 |  | Backing Support 1st Article Test |  | 5d | 2011-09-15 | 2011-09-21 | 142232280 FS-195d | 264d | 75d |  | MECH TECH [40 h]; MECH ENG [20 h] | 3,081.8 |  |  | ELOUADRHIRI L | 1 | 1 |  | LATIFA E |  | 11-026 |  |  |  | 13-002F |  |  |  |  |  |  | 10-017 | 11-021 | 11 -035 |  |  |  | 11-032 |  |  |  |
| 142232175 |  | FTOF Travel FY12 |  | 247d | 2011-10-03 | 2012-09-28 | 142232170 | 20d | 0d |  | TRAVEL | 7,354.97 |  |  | ELOUADRHIRI L | 1 | 1 |  | LATIFA E |  | 11-026 |  |  |  | 13-002F |  |  |  |  |  |  | 10-017 | 11-021 | 11 -035 |  |  |  | 11-032 |  |  |  |
| 142232245 |  | Phase 2a LAL (BC-408) 64 bars |  | 98d | 2011-10-03 | 2012-02-29 | 142232244 FS-58d | 312d | 0d |  | PROCUREMENT<$50K 60 NO ESCALATION | 44,262 |  |  | ELOUADRHIRI L | 1 | 1 |  | LATIFA E |  | 11-026 |  |  |  | 13-002F |  |  |  |  |  |  | 10-017 | 11-021 | 11 -035 |  |  |  | 11-032 |  |  |  |
| 142232246 |  | Phase 2b LAL (BC-408) 64 bars |  | 141d | 2011-10-03 | 2012-04-30 | 142232245 FS-98d | 312d | 0d |  | PROCUREMENT<$50K 60 NO ESCALATION; PROCUREMENT>$50K 69 NO ESCALATION | 44,262 |  |  | ELOUADRHIRI L | 1 | 1 |  | LATIFA E |  | 11-026 |  |  |  | 13-002F |  |  |  |  |  |  | 10-017 | 11-021 | 11 -035 |  |  |  | 11-032 |  |  |  |
| 142232247 |  | Phase 2c LAL (BC-408) 64 bars |  | 183d | 2011-10-03 | 2012-06-29 | 142232246 FS-141d | 312d |  |  | PROCUREMENT>$50K 69 NO ESCALATION | 44,261 |  |  | ELOUADRHIRI L | 1 | 1 |  | LATIFA E |  | 11-026 |  |  |  | 13-002F |  |  |  |  |  |  | 10-017 | 11-021 | 11 -035 |  |  |  | 11-032 |  |  |  |
| 142232356a |  | Final Panel 1-1/1-b manufacturing support FY12 |  | 2d | 2011-10-03 | 2011-10-04 | 142232356 | 39d | 19d |  | MECH DES [2.9 h]; MECH ENG [1.21 h] | 224.54 |  |  | ELOUADRHIRI L | 1 | 1 |  | LATIFA E |  | 11-026 | 12-007 |  |  | 13-002F |  |  |  |  |  |  | 10-017 | 11-021 | 11 -035 |  |  |  | 11-032 |  | 12-001 |  |
| 142232306 |  | Panel-1b magnetic shields procurement prep. |  | 37d | 2011-11-01 | 2011-12-30 | 9-120M FS+21d, 142232205a | 20d | 0d |  | SCIENTIST [40 h] | 2,824.4 |  |  | ELOUADRHIRI L | 1 | 1 |  | LATIFA E |  | 11-026 | 12-007 |  |  | 13-002F |  |  |  |  |  |  | 10-017 | 11-021 | 11 -035 |  |  |  |  |  |  | 11-056 |
| 142232320G |  | Peg Point #6B - Phase 2 assembly start (next 42 units) Part 2 |  | 306d | 2011-11-01 | 2013-01-31 | 142232320F FS-57d | 20d | 0d |  | PROCUREMENT<$50K 60 NO ESCALATION; PROCUREMENT>$50K 69 NO ESCALATION | 115,492 |  |  | ELOUADRHIRI L | 1 | 1 |  | LATIFA E |  | 11-026 |  |  |  | 13-002F |  |  |  |  |  |  | 10-017 | 11-021 | 11 -035 |  |  |  |  |  |  |  |
| 142232360 |  | Complete design of panel-2 support |  | 184d | 2011-11-01 | 2012-07-31 | 9-120M FS+21d, 142232200M | 188d | 0d |  | MECH ENG [180 h]; MECH DES [540 h] | 38,633.4 |  |  | ELOUADRHIRI L | 1 | 1 |  | LATIFA E |  | 11-026 | 12-007 |  |  | 13-002F |  |  |  |  |  |  | 10-017 | 11-021 | 11 -035 |  |  |  | 11-032 |  |  |  |
| 142232361 |  | FTOF storage/work shelves final drawings |  | 57d | 2011-11-01 | 2012-01-31 | 9-120M FS+21d, 142232160 | 25d | 0d |  | MECH ENG [40 h]; MECH DES [80 h] | 6,658.4 |  |  | ELOUADRHIRI L | 1 | 1 |  | LATIFA E |  | 11-026 | 12-007 |  | 12-054F | 13-002F |  |  |  |  |  |  | 10-017 | 11-021 | 11 -035 |  |  |  | 11-032 |  |  | 11-056 |
| 142232371 |  | Panel-1a/2 magnetic shield first article testing |  | 37d | 2011-11-01 | 2011-12-30 | 9-120M FS+21d, 142232356a | 20d | 0d |  | SCIENTIST [120 h] | 8,473.2 |  |  | ELOUADRHIRI L | 1 | 1 |  | LATIFA E |  | 11-026 | 12-007 |  |  | 13-002F |  |  |  |  |  |  | 10-017 | 11-021 | 11 -035 |  |  | 11-001 |  |  |  | 11-056 |
| 142232225 |  | Vend Fab PMT /Divider Peg Point #5 Production Delivery #4 (Qty. 133) |  | 69d | 2011-12-15 | 2012-03-30 | 142232223 FS-7d | 248d | 0d |  | PROCUREMENT<$50K 60 NO ESCALATION; PROCUREMENT>$50K 69 NO ESCALATION | 104,671 |  |  | ELOUADRHIRI L | 1 | 1 |  | LATIFA E |  | 11-026 |  |  |  | 13-002F |  |  |  |  |  |  | 10-017 | 11-021 | 11 -035 |  |  |  |  | 11-009 |  |  |
| 142232226 |  | Vend Fab PMT /Divider Peg Point #6 Production Delivery #5 (Qty. 133) |  | 132d | 2011-12-15 | 2012-06-29 | 142232225 FS-69d | 248d | 0d |  | PROCUREMENT>$50K 69 NO ESCALATION | 104,671 |  |  | ELOUADRHIRI L | 1 | 1 |  | LATIFA E |  | 11-026 |  |  |  | 13-002F |  |  |  |  |  |  | 10-017 | 11-021 | 11 -035 |  |  |  |  | 11-009 |  |  |
| 142232227 |  | Vend Fab PMT /Divider Peg Point #7 Production Delivery #6 (Qty. 134) |  | 196d | 2011-12-15 | 2012-09-28 | 142232226 FS-132d | 248d |  |  | PROCUREMENT>$50K 69 NO ESCALATION | 105,458 |  |  | ELOUADRHIRI L | 1 | 1 |  | LATIFA E |  | 11-026 |  |  |  | 13-002F |  |  |  |  |  |  | 10-017 | 11-021 | 11 -035 |  |  |  |  | 11-009 |  |  |
| 142232307 |  | Panel-1b magnetic shields procurement |  | 232d | 2012-01-03 | 2012-11-30 | 142232306 | 20d | 0d |  | PROCUREMENT<$50K 60 NO ESCALATION FY13; PROCUREMENT>$50K 69 NO ESCALATION FY13 | 74,400 |  |  | ELOUADRHIRI L | 1 | 1 |  | LATIFA E |  | 11-026 | 12-007 |  |  | 13-002F |  |  |  |  |  |  | 10-017 | 11-021 | 11 -035 |  |  |  |  |  |  | 11-056 |
| 142232372 |  | Panel-1a/2 magnetic shields procurement prep. |  | 105d | 2012-01-03 | 2012-05-31 | 142232371 | 20d | 0d |  | SCIENTIST [80 h] | 5,648.8 |  |  | ELOUADRHIRI L | 1 | 1 |  | LATIFA E |  | 11-026 | 12-007 |  |  | 13-002F |  |  |  |  |  |  | 10-017 | 11-021 | 11 -035 |  |  | 11-001 |  |  |  | 11-056 |
| 142232375M |  | Panel 1a Preparation | milestone | 0d | 2012-01-03 | 2012-01-03 | 142232200M FS+392d | 20d | 0d |  |  |  |  |  | ELOUADRHIRI L | 1 | 1 |  | LATIFA E |  | 11-026 |  |  | 12-054F | 13-002F |  |  |  |  |  |  | 10-017 | 11-021 | 11 -035 |  |  |  | 11-032 |  |  |  |
| 142232380 |  | PMT/Divider Procurement Prep - Labor |  | 23d | 2012-01-03 | 2012-02-03 | 142232375M | 325d | 0d |  | SCIENTIST [40 h] | 2,824.4 |  |  | ELOUADRHIRI L | 1 | 1 |  | LATIFA E |  | 11-026 |  |  |  | 13-002F |  |  |  |  |  |  | 10-017 | 11-021 | 11 -035 |  |  |  |  |  |  |  |

Notes:
- 242231425: Steps: Rack #1; Rack #2; Rack #3; Rack #4; Rack #5; Rack #6
- 142232320D: Explanation: Intentional Linear Curve
- 142232320F: Explanation: Intentional Linear Curve
- 142232320G: Explanation: Intentional Linear Curve
- 142232375M: Constraints and Assumptions: Based on Doug Tilles CLAS6 Deinstallation / Schedule.

| ID | Activity | Type | Duration | Start | Finish | Predecessors | Total float | Free float | Resources | Cost | RESP - Responsibility | STRT%COMP for CM EVM | FNSH%COMP for CM EVM | CAM RESPONSIBLE | CR 10-017 | CR 11-021 | CR 11-026 | CR 11-035 | CR 13-002 | CR 11-032 | CR 12-018 | CR 12-054 | CR 13-006 | CR 11-056 | CR 12-007 | CR 11-001 | CR 12-053 | CR 13-014 | CR 12-027 |
| --- | --- | --- | --- | --- | --- | --- | --- | --- | --- | --- | --- | --- | --- | --- | --- | --- | --- | --- | --- | --- | --- | --- | --- | --- | --- | --- | --- | --- | --- |
| 142232390 | Misc. Counter Repair Parts |  | 113d | 2012-01-03 | 2012-06-13 | 142232375M | 324d |  | PROCUREMENT<$50K 60 | 10,648.18 | ELOUADRHIRI L | 1 | 1 | LATIFA E | 10-017 | 11-021 | 11-026 | 11 -035 | 13-002F |  |  |  |  |  |  |  |  |  |  |
| 142232395 | Set up FTOF DAQ and Test Station |  | 127d | 2012-01-03 | 2012-07-03 | 142232375M | 66.88d | 0d | SCIENTIST [400 h] | 28,244 | ELOUADRHIRI L | 1 | 1 | LATIFA E | 10-017 | 11-021 | 11-026 | 11 -035 | 13-002F | 11-032 | 12-018F | 12-054F | 13-006F |  |  |  |  |  |  |
| 142232396 | Calibration test equipment Procurement |  | 83d | 2012-01-03 | 2012-04-30 | 142232375M | 354d |  | PROCUREMENT<$50K 60 | 15,500 | ELOUADRHIRI L | 1 | 1 | LATIFA E | 10-017 | 11-021 | 11-026 | 11 -035 | 13-002F | 11-032 |  |  |  | 11-056 | 12-007 |  |  |  |  |
| 142232549M | Panel 2 preparation | milestone | 0d | 2012-01-03 | 2012-01-03 | 9-120M FS+58d | 312d | 0d |  |  | ELOUADRHIRI L | 1 | 1 | LATIFA E | 10-017 | 11-021 | 11-026 | 11 -035 | 13-002F | 11-032 |  |  |  |  |  |  |  |  |  |
| 142232550 | PMT/Divider Procurement Prep - Labor |  | 62d | 2012-01-03 | 2012-03-30 | 142232549M, 142232200M FS+392d | 312d | 127d | SCIENTIST [40 h] | 2,824.4 | ELOUADRHIRI L | 1 | 1 | LATIFA E | 10-017 | 11-021 | 11-026 | 11 -035 | 13-002F |  |  |  |  |  |  |  |  |  |  |
| 142232362 | FTOF storage/work shelves - procurement prep. |  | 31d | 2012-01-17 | 2012-02-29 | 142232361 FS-11d | 25d | 0d | SCIENTIST [40 h] | 2,824.4 | ELOUADRHIRI L | 1 | 1 | LATIFA E | 10-017 | 11-021 | 11-026 | 11 -035 | 13-002F | 11-032 |  | 12-054F |  | 11-056 | 12-007 |  |  |  |  |
| 142232285 | Backing Support Phase 2 Delivery |  | 238d | 2012-01-18 | 2012-12-31 | 142232281, 142232280 FS-115d | 189d |  | PROCUREMENT<$50K 60 NO ESCALATION FY13; PROCUREMENT>$50K 69 NO ESCALATION FY13 | 77,510.14 | ELOUADRHIRI L | 1 | 1 | LATIFA E | 10-017 | 11-021 | 11-026 | 11 -035 | 13-002F | 11-032 |  |  |  |  |  |  |  |  |  |
| 142232385 | PMT/Divider Procurement |  | 90d | 2012-02-03 | 2012-06-12 | 142232380 FS-1d | 325d |  | PROCUREMENT<$50K 60 | 38,333.43 | ELOUADRHIRI L | 1 | 1 | LATIFA E | 10-017 | 11-021 | 11-026 | 11 -035 | 13-002F |  |  |  |  |  |  |  |  |  |  |
| 142232363 | FTOF storage/work shelves - procurement |  | 65d | 2012-03-01 | 2012-05-31 | 142232362 | 25d | 5d | PROCUREMENT<$50K 60 | 27,000 | ELOUADRHIRI L | 1 | 1 | LATIFA E | 10-017 | 11-021 | 11-026 | 11 -035 | 13-002F | 11-032 |  | 12-054F |  | 11-056 | 12-007 |  |  |  |  |
| 142232354 | Installation tooling load testing |  | 43d | 2012-04-02 | 2012-05-31 | 142232353, 9-120M FS+120d | 23d | 3d | MECH TECH [40 h] | 1,777.6 | ELOUADRHIRI L | 1 | 1 | LATIFA E | 10-017 | 11-021 | 11-026 | 11 -035 | 13-002F | 11-032 |  | 12-054F |  | 11-056 | 12-007 |  |  |  |  |
| 142232373 | Panel-1a/2 magnetic shields procurement |  | 129d | 2012-05-01 | 2012-10-31 | 142232372 FS-22d | 20d | 0d | PROCUREMENT<$50K 60 NO ESCALATION FY13 | 15,500 | ELOUADRHIRI L | 1 | 1 | LATIFA E | 10-017 | 11-021 | 11-026 | 11 -035 | 13-002F |  |  |  |  | 11-056 | 12-007 | 11-001 |  |  |  |
| 142232400 | Deinstallation S1 |  | 2d | 2012-06-07 | 2012-06-08 | 142232375M FS+108d, 142232354 | 20d | 0d |  |  | ELOUADRHIRI L | 1 | 1 | LATIFA E | 10-017 | 11-021 | 11-026 | 11 -035 | 13-002F | 11-032 |  | 12-054F |  |  |  |  |  |  |  |
| 142232420 | Deinstallation S2 |  | 2d | 2012-06-08 | 2012-06-11 | 142232405 FS-3d | 20d | 0d |  |  | ELOUADRHIRI L | 1 | 1 | LATIFA E | 10-017 | 11-021 | 11-026 | 11 -035 | 13-002F | 11-032 |  | 12-054F |  |  |  |  |  |  |  |
| 142232425 | Move S2 to storage |  | 2d | 2012-06-08 | 2012-06-11 | 142232420 FS-2d | 20d | 0d |  |  | ELOUADRHIRI L | 1 | 1 | LATIFA E | 10-017 | 11-021 | 11-026 | 11 -035 | 13-002F | 11-032 |  | 12-054F |  |  |  |  |  |  |  |
| 142232405 | Move S1 to storage |  | 2d | 2012-06-11 | 2012-06-12 | 142232375M FS+108d, 142232363, 142232400 | 20d | 0d | PROCUREMENT<$50K 60 | 2,579.75 | ELOUADRHIRI L | 1 | 1 | LATIFA E | 10-017 | 11-021 | 11-026 | 11 -035 | 13-002F | 11-032 |  | 12-054F |  |  |  |  |  |  |  |
| 142232440 | Deinstallation S3 |  | 1d | 2012-06-11 | 2012-06-11 | 142232425 FS-1d | 20d | 0d |  |  | ELOUADRHIRI L | 1 | 1 | LATIFA E | 10-017 | 11-021 | 11-026 | 11 -035 | 13-002F | 11-032 |  | 12-054F |  |  |  |  |  |  |  |
| 142232445 | Move S3 to storage |  | 1d | 2012-06-11 | 2012-06-11 | 142232440 FS-1d | 20d | 0d |  |  | ELOUADRHIRI L | 1 | 1 | LATIFA E | 10-017 | 11-021 | 11-026 | 11 -035 | 13-002F | 11-032 |  | 12-054F |  |  |  |  |  |  |  |
| 142232460 | Deinstallation S4 |  | 2d | 2012-06-11 | 2012-06-12 | 142232445 FS-1d | 20d | 0d |  |  | ELOUADRHIRI L | 1 | 1 | LATIFA E | 10-017 | 11-021 | 11-026 | 11 -035 | 13-002F | 11-032 |  | 12-054F |  |  |  |  |  |  |  |
| 142232465 | Move S4 to storage |  | 2d | 2012-06-11 | 2012-06-12 | 142232460 FS-2d | 20d | 0d |  |  | ELOUADRHIRI L | 1 | 1 | LATIFA E | 10-017 | 11-021 | 11-026 | 11 -035 | 13-002F | 11-032 |  | 12-054F |  |  |  |  |  |  |  |
| 142232480 | Deinstallation S5 |  | 1d | 2012-06-12 | 2012-06-12 | 142232465 FS-1d | 20d | 0d |  |  | ELOUADRHIRI L | 1 | 1 | LATIFA E | 10-017 | 11-021 | 11-026 | 11 -035 | 13-002F | 11-032 |  | 12-054F |  |  |  |  |  |  |  |
| 142232485 | Move S5 to storage |  | 1d | 2012-06-12 | 2012-06-12 | 142232480 FS-1d | 20d | 0d |  |  | ELOUADRHIRI L | 1 | 1 | LATIFA E | 10-017 | 11-021 | 11-026 | 11 -035 | 13-002F | 11-032 |  | 12-054F |  |  |  |  |  |  |  |
| 142232500 | Deinstallation S6 |  | 1d | 2012-06-13 | 2012-06-13 | 142232485 | 20d | 0d |  |  | ELOUADRHIRI L | 1 | 1 | LATIFA E | 10-017 | 11-021 | 11-026 | 11 -035 | 13-002F | 11-032 |  | 12-054F |  |  |  |  |  |  |  |
| 142232505 | Move S6 to storage |  | 1d | 2012-06-14 | 2012-06-14 | 142232500 | 20d | 0d |  |  | ELOUADRHIRI L | 1 | 1 | LATIFA E | 10-017 | 11-021 | 11-026 | 11 -035 | 13-002F | 11-032 |  | 12-054F |  |  |  |  |  |  |  |
| 142232565 | Deinstallation |  | 20d | 2012-06-15 | 2012-07-12 | 142232505 | 20d | 0d |  |  | ELOUADRHIRI L | 1 | 1 | LATIFA E | 10-017 | 11-021 | 11-026 | 11 -035 | 13-002F | 11-032 |  | 12-054F |  |  |  |  |  |  |  |
| 142232570 | Move Panel 2 to storage |  | 20d | 2012-06-15 | 2012-07-12 | 142232565 FS-20d | 20d | 0d | PROCUREMENT<$50K 60 | 2,579.75 | ELOUADRHIRI L | 1 | 1 | LATIFA E | 10-017 | 11-021 | 11-026 | 11 -035 | 13-002F | 11-032 |  | 12-054F |  |  |  |  |  |  |  |
| 142232654 | Support frame procurement prep |  | 10d | 2012-06-19 | 2012-07-02 | 9-120M FS+174d | 188d | 0d | SCIENTIST [80 h] | 5,648.8 | ELOUADRHIRI L | 1 | 1 | LATIFA E | 10-017 | 11-021 | 11-026 | 11 -035 | 13-002F | 11-032 |  |  |  |  |  |  |  |  |  |
| 142232410 | S1 Counter QA and baseline measurements |  | 21d | 2012-07-02 | 2012-07-30 | 142232375M FS+23d, 142232405 FS+13d | 86d | 66d | MECH TECH [160 h] | 7,110.4 | ELOUADRHIRI L | 1 | 1 | LATIFA E | 10-017 | 11-021 | 11-026 | 11 -035 | 13-002F |  |  |  |  |  | 12-007 |  |  |  |  |
| 142232655 | Panel 2 Support Frame Procurement |  | 123d | 2012-07-03 | 2013-01-02 | 142232565 FS-55d, 142232360 FS-21d, 142232654 | 188d |  | PROCUREMENT<$50K 60 NO ESCALATION FY13 | 47,423.03 | ELOUADRHIRI L | 1 | 1 | LATIFA E | 10-017 | 11-021 | 11-026 | 11 -035 | 13-002F | 11-032 |  |  |  |  |  |  |  |  |  |
| 142232580 | Set up FTOF DAQ + Test Station FY12 |  | 61d | 2012-07-05 | 2012-09-28 | 142232395 FS+1d | 66.88d | 0d | SCIENTIST [62.46 h] | 4,410.3 | ELOUADRHIRI L | 1 | 1 | LATIFA E | 10-017 | 11-021 | 11-026 | 11 -035 | 13-002F | 11-032 | 12-018F | 12-054F | 13-006F |  |  |  | 12-053 |  |  |
| 142232575 | Extract panel-2 counters from CLAS6 FY12 |  | 55d | 2012-07-13 | 2012-09-28 | 142232570 | 20d | 0d | MECH TECH [356.76 h] | 15,854.41 | ELOUADRHIRI L | 1 | 1 | LATIFA E | 10-017 | 11-021 | 11-026 | 11 -035 | 13-002F | 11-032 |  | 12-054F |  |  |  |  | 12-053 |  |  |
| 142232560 | Misc. Repair Parts |  | 209d | 2012-08-01 | 2013-06-05 | 142232200M FS+539d | 81d |  | PROCUREMENT<$50K 60 NO ESCALATION FY13 | 10,648.18 | ELOUADRHIRI L | 1 | 1 | LATIFA E | 10-017 | 11-021 | 11-026 | 11 -035 | 13-002F |  |  |  |  |  |  |  |  |  |  |
| 142232180 | FTOF Travel FY13 |  | 228d | 2012-10-01 | 2013-08-30 | 142232175 | 20d |  | TRAVEL | 6,977.53 | ELOUADRHIRI L | 1 | 1 | LATIFA E | 10-017 | 11-021 | 11-026 | 11 -035 | 13-002F | 11-032 |  |  |  |  |  |  |  | 13-014 |  |
| 142232555 | PMT/Divider Procurement |  | 63d | 2012-10-01 | 2013-01-07 | 142232550, 9-130M | 185d |  | PROCUREMENT<$50K 60 | 39,556.27 | ELOUADRHIRI L | 1 | 1 | LATIFA E | 10-017 | 11-021 | 11-026 | 11 -035 | 13-002F |  |  |  |  |  |  |  |  |  | 12-027 |
| 142232575a | Extract panel-2 counters from CLAS6 FY13 |  | 19d | 2012-10-01 | 2012-10-25 | 142232575 | 20d | 0d | MECH TECH [123.24 h] | 5,651.79 | ELOUADRHIRI L | 1 | 1 | LATIFA E | 10-017 | 11-021 | 11-026 | 11 -035 | 13-002F | 11-032 |  | 12-054F |  |  |  |  | 12-053 |  |  |
| 142232580a | Set up FTOF DAQ + Test Station FY13 |  | 17.12d | 2012-10-01 | 2012-10-24 | 142232580 | 66.88d | 46.88d | SCIENTIST [17.54 h] | 1,277.96 | ELOUADRHIRI L | 1 | 1 | LATIFA E | 10-017 | 11-021 | 11-026 | 11 -035 | 13-002F | 11-032 | 12-018F | 12-054F | 13-006F |  |  |  | 12-053 |  |  |
| 142232231 | Forward carriage patch panels procurement prep. |  | 36d | 2012-11-01 | 2012-12-31 | 9-130M FS+23d, 142232160 | 42d | 0d | SCIENTIST [40 h] | 2,914.4 | ELOUADRHIRI L | 1 | 1 | LATIFA E | 10-017 | 11-021 | 11-026 | 11 -035 | 13-002F | 11-032 |  |  |  | 11-056 | 12-007 | 11-001 |  |  |  |
| 142232233 | Patch panel to electronics cables procurement prep. |  | 36d | 2012-11-01 | 2012-12-31 | 9-130M FS+23d, 142232160 | 106d | 0d | SCIENTIST [40 h] | 2,914.4 | ELOUADRHIRI L | 1 | 1 | LATIFA E | 10-017 | 11-021 | 11-026 | 11 -035 | 13-002F | 11-032 |  |  |  | 11-056 | 12-007 | 11-001 |  |  |  |
| 142232250 | Signal Cable Procurement Prep - Labor |  | 57d | 2012-11-01 | 2013-01-31 | 142232200M FS+604d | 105d | 0d | SCIENTIST [40 h] | 2,914.4 | ELOUADRHIRI L | 1 | 1 | LATIFA E | 10-017 | 11-021 | 11-026 | 11 -035 | 13-002F |  |  |  |  |  |  |  |  |  |  |
| 142232260 | High Voltage Cable Procurement Prep - Labor |  | 57d | 2012-11-01 | 2013-01-31 | 142232200M FS+604d | 105d | 0d | SCIENTIST [40 h] | 2,914.4 | ELOUADRHIRI L | 1 | 1 | LATIFA E | 10-017 | 11-021 | 11-026 | 11 -035 | 13-002F |  |  |  |  |  |  |  |  |  |  |
| 142232290 | Support Frame Procurement Prep - Labor |  | 57d | 2012-11-01 | 2013-01-31 | 142232200M FS+604d | 84d | 0d | SCIENTIST [80 h] | 5,828.8 | ELOUADRHIRI L | 1 | 1 | LATIFA E | 10-017 | 11-021 | 11-026 | 11 -035 | 13-002F |  |  |  |  |  |  |  |  |  |  |
| 142232300 | Divider adaptor Procurement Prep - Labor |  | 57d | 2012-11-01 | 2013-01-31 | 142232200M FS+604d | 105d | 0d | SCIENTIST [40 h] | 2,914.4 | ELOUADRHIRI L | 1 | 1 | LATIFA E | 10-017 | 11-021 | 11-026 | 11 -035 | 13-002F |  |  |  |  |  |  |  |  |  |  |
| 142232320H | Peg Point #6C - Phase 2 assembly start (next 42 units) Part 3 |  | 57d | 2012-11-01 | 2013-01-31 | 142232320G FS-57d | 20d | 0d | PROCUREMENT>$50K 69 NO ESCALATION; PROCUREMENT<$50K 60 NO ESCALATION | 68,244.69 | ELOUADRHIRI L | 1 | 1 | LATIFA E | 10-017 | 11-021 | 11-026 | 11 -035 | 13-002F |  |  |  |  |  |  |  |  |  |  |
| 142232320J | Peg Point #7 - Phase 3 assembly start (last 17 units) |  | 161d | 2012-11-01 | 2013-06-28 | 142232320H FS-57d | 20d | 0d | PROCUREMENT>$50K 69 NO ESCALATION | 38,679.95 | ELOUADRHIRI L | 1 | 1 | LATIFA E | 10-017 | 11-021 | 11-026 | 11 -035 | 13-002F |  |  |  |  |  |  |  |  |  |  |
| 142232320K | Peg Point #8 - JLab Acceptance Test preparation start |  | 161d | 2012-11-01 | 2013-06-28 | 142232307 FS-20d, 142232320J FS-161d | 20d | 0d | PROCUREMENT>$50K 69 NO ESCALATION | 14,239.81 | ELOUADRHIRI L | 1 | 1 | LATIFA E | 10-017 | 11-021 | 11-026 | 11 -035 | 13-002F |  |  |  |  |  |  |  |  |  |  |
| 142232320N | Peg Point #9 - Panel-1b counters delivered to JLab |  | 161d | 2012-11-01 | 2013-06-28 | 142232320K FS-161d | 20d | 0d | PROCUREMENT>$50K 69 NO ESCALATION | 28,702.47 | ELOUADRHIRI L | 1 | 1 | LATIFA E | 10-017 | 11-021 | 11-026 | 11 -035 | 13-002F |  |  |  |  |  |  |  |  |  |  |
| 142232320P | Peg Point #10 - Sector assembly start |  | 205d | 2012-11-01 | 2013-08-30 | 142232320N FS-161d | 20d |  | PROCUREMENT>$50K 69 NO ESCALATION | 37,107.77 | ELOUADRHIRI L | 1 | 1 | LATIFA E | 10-017 | 11-021 | 11-026 | 11 -035 | 13-002F |  |  |  |  |  |  |  |  |  |  |
| 142232415 | S1 repair |  | 21d | 2012-11-01 | 2012-12-03 | 142232373, 142232410 | 20d | 0d | MECH TECH [171.43 h]; SCIENTIST [28.57 h] | 9,943.39 | ELOUADRHIRI L | 1 | 1 | LATIFA E | 10-017 | 11-021 | 11-026 | 11 -035 | 13-002F | 11-032 |  |  |  |  | 12-007 |  |  |  |  |
| 142232430 | S2 Counter QA and baseline measurements |  | 20d | 2012-12-04 | 2013-01-08 | 142232425, 142232415 | 20d | 0d | MECH TECH [160 h] | 7,337.6 | ELOUADRHIRI L | 1 | 1 | LATIFA E | 10-017 | 11-021 | 11-026 | 11 -035 | 13-002F |  |  |  |  |  | 12-007 |  |  |  |  |
| 142232232 | Forward carriage patch panels procurement |  | 147d | 2013-01-02 | 2013-07-31 | 142232231 | 42d |  | PROCUREMENT<$50K 60; PROCUREMENT>$50K 69 | 53,658.8 | ELOUADRHIRI L | 1 | 1 | LATIFA E | 10-017 | 11-021 | 11-026 | 11 -035 | 13-002F | 11-032 |  |  |  | 11-056 | 12-007 | 11-001 |  |  |  |
| 142232234 | Patch panel to electronics cables procurement |  | 83d | 2013-01-02 | 2013-04-30 | 142232233 | 106d |  | PROCUREMENT<$50K 60 | 23,011.37 | ELOUADRHIRI L | 1 | 1 | LATIFA E | 10-017 | 11-021 | 11-026 | 11 -035 | 13-002F | 11-032 |  |  |  | 11-056 | 12-007 | 11-001 |  |  |  |
| 142232520 | Frame Modification Support Piece Procurement |  | 40d | 2013-01-02 | 2013-02-28 | 142232355, 142232356a, 142232375M FS+248d | 139d | 0d | PROCUREMENT<$50K 60 | 16,481.78 | ELOUADRHIRI L | 1 | 1 | LATIFA E | 10-017 | 11-021 | 11-026 | 11 -035 | 13-002F |  |  |  |  |  |  |  |  |  |  |
| 142232435 | S2 repair |  | 21d | 2013-01-09 | 2013-02-07 | 142232430 | 20d | 0d | MECH TECH [171.43 h]; SCIENTIST [28.57 h] | 9,943.39 | ELOUADRHIRI L | 1 | 1 | LATIFA E | 10-017 | 11-021 | 11-026 | 11 -035 | 13-002F | 11-032 |  |  |  |  | 12-007 |  |  |  |  |
| 142232585 | Counter QA and baseline measurements |  | 52d | 2013-01-09 | 2013-03-25 | 142232580a, 142232575a FS+45d | 20d | 0d | MECH TECH [240 h] | 11,006.4 | ELOUADRHIRI L | 1 | 1 | LATIFA E | 10-017 | 11-021 | 11-026 | 11 -035 | 13-002F | 11-032 |  | 12-054 |  |  |  |  | 12-053 |  |  |
| 142232255 | Signal Cable Procurement |  | 63d | 2013-02-01 | 2013-05-01 | 142232250 | 105d |  | PROCUREMENT<$50K 60 | 28,678.3 | ELOUADRHIRI L | 1 | 1 | LATIFA E | 10-017 | 11-021 | 11-026 | 11 -035 | 13-002F |  |  |  |  |  |  |  |  |  |  |
| 142232265 | High Voltage Cable Procurement |  | 63d | 2013-02-01 | 2013-05-01 | 142232260 | 105d |  | PROCUREMENT<$50K 60 | 53,400.97 | ELOUADRHIRI L | 1 | 1 | LATIFA E | 10-017 | 11-021 | 11-026 | 11 -035 | 13-002F |  |  |  |  |  |  |  |  |  |  |
| 142232295 | Support Frame Procurement |  | 84d | 2013-02-01 | 2013-05-31 | 142232290, 142232350 | 84d |  | PROCUREMENT<$50K 60 | 35,161.13 | ELOUADRHIRI L | 1 | 1 | LATIFA E | 10-017 | 11-021 | 11-026 | 11 -035 | 13-002F |  |  |  |  |  |  |  |  |  |  |
| 142232305 | Divider adaptor procurement |  | 63d | 2013-02-01 | 2013-05-01 | 142232300 | 105d |  | PROCUREMENT<$50K 60 | 43,951.41 | ELOUADRHIRI L | 1 | 1 | LATIFA E | 10-017 | 11-021 | 11-026 | 11 -035 | 13-002F |  |  |  |  |  |  |  |  |  |  |
| 142232450 | S3 Counter QA and baseline measurements |  | 19d | 2013-02-08 | 2013-03-07 | 142232435 | 20d | 0d | MECH TECH [160 h] | 7,337.6 | ELOUADRHIRI L | 1 | 1 | LATIFA E | 10-017 | 11-021 | 11-026 | 11 -035 | 13-002F |  |  |  |  |  | 12-007 |  |  |  |  |
| 142232525 | Install Frame Support Pieces |  | 10d | 2013-03-01 | 2013-03-14 | 142232520 | 139d |  | MECH TECH [80 h] | 3,668.8 | ELOUADRHIRI L | 1 | 1 | LATIFA E | 10-017 | 11-021 | 11-026 | 11 -035 | 13-002F |  |  |  |  |  |  |  |  |  |  |
| 142232455 | S3 repair |  | 20d | 2013-03-08 | 2013-04-04 | 142232450 | 20d | 0d | MECH TECH [171.43 h]; SCIENTIST [28.57 h] | 9,943.39 | ELOUADRHIRI L | 1 | 1 | LATIFA E | 10-017 | 11-021 | 11-026 | 11 -035 | 13-002F | 11-032 |  |  |  |  | 12-007 |  |  |  |  |
| 142232590 | Counter repair |  | 112d | 2013-03-26 | 2013-08-30 | 142232585 | 20d | 0d | MECH TECH [888.6 h] | 40,751.2 | ELOUADRHIRI L | 1 | 1 | LATIFA E | 10-017 | 11-021 | 11-026 | 11 -035 | 13-002F | 11-032 |  | 12-054 |  |  | 12-007 |  |  | 13-014 |  |
| 142232535 | Set up FTOF DAQ + Test Station |  | 59d | 2013-04-01 | 2013-06-21 | 142232530 FS-63d | 20d | 0d | SCIENTIST [40 h] | 2,914.4 | ELOUADRHIRI L | 1 | 1 | LATIFA E | 10-017 | 11-021 | 11-026 | 11 -035 | 13-002F |  |  |  |  |  |  |  |  |  |  |
| 142232470 | S4 Counter QA and baseline measurements |  | 15d | 2013-04-05 | 2013-04-25 | 142232455 | 20d | 0d | MECH TECH [160 h] | 7,337.6 | ELOUADRHIRI L | 1 | 1 | LATIFA E | 10-017 | 11-021 | 11-026 | 11 -035 | 13-002F |  |  |  |  |  | 12-007 |  |  |  |  |
| 142232475 | S4 repair |  | 20d | 2013-04-26 | 2013-05-23 | 142232470 | 20d | 0d | SCIENTIST [28.57 h]; MECH TECH [171.43 h] | 9,943.39 | ELOUADRHIRI L | 1 | 1 | LATIFA E | 10-017 | 11-021 | 11-026 | 11 -035 | 13-002F | 11-032 |  |  |  |  | 12-007 |  |  |  |  |
| 142232530 | Prepare JLAB construction space |  | 33d | 2013-05-13 | 2013-06-27 | 142232320N FS-34d | 20d | 0d | MECH TECH [40 h] | 1,834.4 | ELOUADRHIRI L | 1 | 1 | LATIFA E | 10-017 | 11-021 | 11-026 | 11 -035 | 13-002F |  |  |  |  |  |  |  |  |  |  |
| 142232490 | S5 Counter QA and baseline measurements |  | 21d | 2013-05-24 | 2013-06-24 | 142232475 | 20d | 0d | MECH TECH [160 h] | 7,337.6 | ELOUADRHIRI L | 1 | 1 | LATIFA E | 10-017 | 11-021 | 11-026 | 11 -035 | 13-002F |  |  |  |  |  | 12-007 |  |  |  |  |
| 142232540 | Unload counters |  | 4d | 2013-06-24 | 2013-06-27 | 142232535 | 20d | 0d | MECH TECH [40 h] | 1,834.4 | ELOUADRHIRI L | 1 | 1 | LATIFA E | 10-017 | 11-021 | 11-026 | 11 -035 | 13-002F | 11-032 |  |  |  |  |  |  |  |  |  |
| 142232495 | S5 repair |  | 21d | 2013-06-25 | 2013-07-24 | 142232490 | 20d | 0d | MECH TECH [171.43 h]; SCIENTIST [28.57 h] | 9,943.39 | ELOUADRHIRI L | 1 | 1 | LATIFA E | 10-017 | 11-021 | 11-026 | 11 -035 | 13-002F | 11-032 |  |  |  |  | 12-007 |  |  |  |  |
| 142232510 | S6 Counter QA and baseline measurements |  | 21d | 2013-07-25 | 2013-08-22 | 142232495 | 20d | 0d | MECH TECH [160 h] | 7,337.6 | ELOUADRHIRI L | 1 | 1 | LATIFA E | 10-017 | 11-021 | 11-026 | 11 -035 | 13-002F |  |  |  |  |  | 12-007 |  |  |  |  |
| 142232545 | Mount counters to support frame |  | 25d | 2013-07-29 | 2013-08-30 | 142232540 FS+20d | 20d | 0d | MECH TECH [45.98 h] | 2,108.64 | ELOUADRHIRI L | 1 | 1 | LATIFA E | 10-017 | 11-021 | 11-026 | 11 -035 | 13-002F |  |  |  |  |  |  |  |  | 13-014 |  |

Notes:
- 142232565: Constraints and Assumptions: Comes from Doug Tilles CLAS6 Deinstallation / Schedule.
- 142232320H: Explanation: Intentional Linear Curve

| ID | Activity | Type | Duration | Start | Finish | Predecessors | Total float | Free float | Calendar | Resources | Cost | RESP - Responsibility | STRT%COMP for CM EVM | FNSH%COMP for CM EVM | CAM RESPONSIBLE | CR 10-017 | CR 11-021 | CR 11-026 | CR 11-032 | CR 11-035 | CR 12-007 | CR 12-054 | CR 13-002 | CR 13-014 | ReBaseline Actuals Adjustment | Original Activity ID Rebaseline | EVMS Reporting Codes | BOE Expenses | CR 13-015 | Post Rebaseline | Over Under Fixed | BOE Procurement | Obligated Prior to Rebaseline | BOE Labor | CR 14-001 | CR 11-001 | CR 11-056 | CR 13-010 |
| --- | --- | --- | --- | --- | --- | --- | --- | --- | --- | --- | --- | --- | --- | --- | --- | --- | --- | --- | --- | --- | --- | --- | --- | --- | --- | --- | --- | --- | --- | --- | --- | --- | --- | --- | --- | --- | --- | --- |
| 142232595 | Mount S1 counters to frame |  | 10d | 2013-07-30 | 2013-08-12 | 142232590 FS-24d | 20d | 0d |  | MECH TECH [80 h] | 3,668.8 | ELOUADRHIRI L | 1 | 1 | LATIFA E | 10-017 | 11-021 | 11-026 | 11-032 | 11 -035 | 12-007 | 12-054 | 13-002F |  |  |  |  |  |  |  |  |  |  |  |  |  |  |  |
| 142232546 | Panel 1-b QA and baseline measurements |  | 22d | 2013-08-01 | 2013-08-30 | 142232545 FS-22d | 20d |  |  | MECH TECH [156.83 h] | 7,192.22 | ELOUADRHIRI L | 1 | 1 | LATIFA E | 10-017 | 11-021 | 11-026 | 11-032 | 11 -035 | 12-007 |  | 13-002F | 13-014 |  |  |  |  |  |  |  |  |  |  |  |  |  |  |
| 142232600 | S1 panel-2 QA |  | 5d | 2013-08-13 | 2013-08-19 | 142232595 | 20d | 0d |  | MECH TECH [40 h] | 1,834.4 | ELOUADRHIRI L | 1 | 1 | LATIFA E | 10-017 | 11-021 | 11-026 | 11-032 | 11 -035 | 12-007 | 12-054 | 13-002F |  |  |  |  |  |  |  |  |  |  |  |  |  |  |  |
| 142232605 | Mount S2 counters to frames |  | 9d | 2013-08-20 | 2013-08-30 | 142232600 | 20d |  |  | MECH TECH [72 h] | 3,301.92 | ELOUADRHIRI L | 1 | 1 | LATIFA E | 10-017 | 11-021 | 11-026 | 11-032 | 11 -035 | 12-007 | 12-054 | 13-002F | 13-014 |  |  |  |  |  |  |  |  |  |  |  |  |  |  |
| 142232515 | S6 repair |  | 6d | 2013-08-23 | 2013-08-30 | 142232510 | 20d |  |  | MECH TECH [51.43 h]; SCIENTIST [8.57 h] | 2,983.01 | ELOUADRHIRI L | 1 | 1 | LATIFA E | 10-017 | 11-021 | 11-026 | 11-032 | 11 -035 | 12-007 |  | 13-002F | 13-014 |  |  |  |  |  |  |  |  |  |  |  |  |  |  |
| 142232610 | S2 panel-2 QA (Future Activity Complete prior to Rebaseline) |  | 1d | 2013-08-30 | 2013-08-30 | 9-130M FS+227d | 20d |  |  | MECH TECH |  | ELOUADRHIRI L | 1 | 1 | LATIFA E | 10-017 | 11-021 | 11-026 | 11-032 | 11 -035 | 12-007 | 12-054 | 13-002F | 13-014 |  |  |  |  |  |  |  |  |  |  |  |  |  |  |
| 142232615 | Mount S3 counters to frames (Future Activity Complete prior to Rebaseline) |  | 1d | 2013-08-30 | 2013-08-30 | 9-130M FS+227d | 20d |  |  | MECH TECH |  | ELOUADRHIRI L | 1 | 1 | LATIFA E | 10-017 | 11-021 | 11-026 | 11-032 | 11 -035 | 12-007 | 12-054 | 13-002F | 13-014 |  |  |  |  |  |  |  |  |  |  |  |  |  |  |
| 142232620 | S3 panel-2 QA (Future Activity Complete prior to Rebaseline) |  | 1d | 2013-08-30 | 2013-08-30 | 9-130M FS+227d | 20d |  |  | MECH TECH |  | ELOUADRHIRI L | 1 | 1 | LATIFA E | 10-017 | 11-021 | 11-026 | 11-032 | 11 -035 | 12-007 | 12-054 | 13-002F | 13-014 |  |  |  |  |  |  |  |  |  |  |  |  |  |  |
| 142232625 | Mount S4 counters to frames (Future Activity Complete prior to Rebaseline) |  | 1d | 2013-08-30 | 2013-08-30 | 9-130M FS+227d | 20d |  |  | MECH TECH |  | ELOUADRHIRI L | 1 | 1 | LATIFA E | 10-017 | 11-021 | 11-026 | 11-032 | 11 -035 | 12-007 | 12-054 | 13-002F | 13-014 |  |  |  |  |  |  |  |  |  |  |  |  |  |  |
| 142232630 | S4 panel-2 QA (Future Activity Complete prior to Rebaseline) |  | 1d | 2013-08-30 | 2013-08-30 | 9-130M FS+227d | 20d |  |  | MECH TECH |  | ELOUADRHIRI L | 1 | 1 | LATIFA E | 10-017 | 11-021 | 11-026 | 11-032 | 11 -035 | 12-007 | 12-054 | 13-002F | 13-014 |  |  |  |  |  |  |  |  |  |  |  |  |  |  |
| 142232635 | Mount S5 counters to frames (Future Activity Complete prior to Rebaseline) |  | 1d | 2013-08-30 | 2013-08-30 | 9-130M FS+227d | 20d |  |  | MECH TECH |  | ELOUADRHIRI L | 1 | 1 | LATIFA E | 10-017 | 11-021 | 11-026 | 11-032 | 11 -035 | 12-007 | 12-054 | 13-002F | 13-014 |  |  |  |  |  |  |  |  |  |  |  |  |  |  |
| 142232640 | S5 panel-2 QA (Future Activity Complete prior to Rebaseline) |  | 1d | 2013-08-30 | 2013-08-30 | 9-130M FS+227d | 20d |  |  | MECH TECH |  | ELOUADRHIRI L | 1 | 1 | LATIFA E | 10-017 | 11-021 | 11-026 | 11-032 | 11 -035 | 12-007 | 12-054 | 13-002F | 13-014 |  |  |  |  |  |  |  |  |  |  |  |  |  |  |
| 142232645 | Mount S6 counters to frames (Future Activity Complete prior to Rebaseline) |  | 1d | 2013-08-30 | 2013-08-30 | 9-130M FS+227d | 20d |  |  | MECH TECH |  | ELOUADRHIRI L | 1 | 1 | LATIFA E | 10-017 | 11-021 | 11-026 | 11-032 | 11 -035 | 12-007 | 12-054 | 13-002F | 13-014 |  |  |  |  |  |  |  |  |  |  |  |  |  |  |
| 142232650 | S6 panel-2 QA (Future Activity Complete prior to Rebaseline) |  | 1d | 2013-08-30 | 2013-08-30 | 9-130M FS+227d | 20d |  |  | MECH TECH |  | ELOUADRHIRI L | 1 | 1 | LATIFA E | 10-017 | 11-021 | 11-026 | 11-032 | 11 -035 | 12-007 | 12-054 | 13-002F | 13-014 |  |  |  |  |  |  |  |  |  |  |  |  |  |  |
| 142232660 | Panel 1-a and Panel 2 signal cables and connectors (672) - proc (Future Activity Complete prior to Rebaseline) |  | 1d | 2013-08-30 | 2013-08-30 | 9-130M FS+227d | 20d |  |  | PROCUREMENT<$50K 60 |  | ELOUADRHIRI L | 1 | 1 | LATIFA E | 10-017 | 11-021 | 11-026 | 11-032 | 11 -035 |  | 12-054 | 13-002F | 13-014 |  |  |  |  |  |  |  |  |  |  |  |  |  |  |
| 142232665 | Panel 1-a and Panel 2 signal cables and connectors (672) - assy&test (Future Activity Complete prior to Rebaseline) |  | 1d | 2013-08-30 | 2013-08-30 | 9-130M FS+227d | 20d |  |  | ELEC TECH |  | ELOUADRHIRI L | 1 | 1 | LATIFA E | 10-017 | 11-021 | 11-026 | 11-032 | 11 -035 |  | 12-054 | 13-002F | 13-014 |  |  |  |  |  |  |  |  |  |  |  |  |  |  |
| 142232680 | Panel 1-a and panel 2 HV cable testing (Future Activity Complete prior to Rebaseline) |  | 1d | 2013-08-30 | 2013-08-30 | 9-130M FS+227d | 20d |  |  | ELEC TECH |  | ELOUADRHIRI L | 1 | 1 | LATIFA E | 10-017 | 11-021 | 11-026 | 11-032 | 11 -035 |  | 12-054 | 13-002F | 13-014 |  |  |  |  |  |  |  |  |  |  |  |  |  |  |
| 142232690 | Re-Baseline Actuals Adjustment |  | 1d | 2013-08-30 | 2013-08-30 | 9-130M FS+227d | 20d |  |  | PROCUREMENT>$50K 69 NO ESCALATION | -159,761.25 | ELOUADRHIRI L | 1 | 1 | LATIFA E |  |  |  |  |  |  |  |  | 13-014 | ADJ |  |  |  |  |  |  |  |  |  |  |  |  |  |
| 242232180 | FTOF Travel FY13 |  | 20d | 2013-09-03 | 2013-09-30 | 9-130M FS+228d | 494d | 0d | 8/5 M-F w/JLAB Holidays ReBaseline | TRAVEL | 611.93 | ELOUADRHIRI L | 1 | 1 | LATIFA E | 10-017 | 11-021 | 11-026 | 11-032 | 11 -035 |  |  | 13-002F |  |  | 242232180 | E | PE | 13-015 | PR |  |  |  |  |  |  |  |  |
| 242232320Q | Peg Point #11 - Counter baseline measurements complete |  | 77d | 2013-09-03 | 2013-12-20 | 9-130M FS+228d | 456d | 0d | 8/5 M-F w/JLAB Holidays ReBaseline | PROCUREMENT<$50K 60 NO ESCALATION; PROCUREMENT>$50K 69 NO ESCALATION | 53,642.72 | ELOUADRHIRI L | 1 | 1 | LATIFA E | 10-017 | 11-021 | 11-026 |  | 11 -035 |  |  | 13-002F |  |  | 242232320Q | D |  | 13-015 | PR | y | OB | OB |  |  |  |  |  |
| 242232320R | Peg Point #12 - Panel-1b assembly and testing complete |  | 77d | 2013-09-03 | 2013-12-20 | 242232320Q FS-77d | 456d | 0d | 8/5 M-F w/JLAB Holidays ReBaseline | PROCUREMENT>$50K 69 NO ESCALATION | 121,530.65 | ELOUADRHIRI L | 1 | 1 | LATIFA E | 10-017 | 11-021 | 11-026 |  | 11 -035 |  |  | 13-002F |  |  | 242232320R | D |  | 13-015 | PR | y | OB | OB |  |  |  |  |  |
| 242232546 | Panel 1-b QA and baseline measurements FY13 |  | 20d | 2013-09-03 | 2013-09-30 | 9-130M FS+228d | 453d | 0d | 8/5 M-F w/JLAB Holidays ReBaseline | MECH TECH [27.12 h]; CONTRB UNIV LBR [433.9 h] | 1,243.67 | ELOUADRHIRI L | 1 | 1 | LATIFA E | 10-017 | 11-021 | 11-026 | 11-032 | 11 -035 | 12-007 |  | 13-002F |  |  | 242232546 | U |  | 13-015 | PR |  |  |  | PE |  |  |  |  |
| 242232655 | Panel 2 Support Frame Procurement |  | 139d | 2013-09-03 | 2014-03-31 | 9-130M FS+228d | 453d | 0d | 8/5 M-F w/JLAB Holidays ReBaseline | PROCUREMENT<$50K 60 NO ESCALATION FY14 | 4,471.68 | ELOUADRHIRI L | 1 | 1 | LATIFA E | 10-017 | 11-021 | 11-026 | 11-032 | 11 -035 |  |  | 13-002F |  |  | 242232655 | D |  | 13-015 | PR |  | EJ |  |  |  |  |  |  |
| 242232185 | FTOF Travel FY14 |  | 57d | 2013-10-01 | 2013-12-20 | 242232180 | 494d | 41d | 8/5 M-F w/JLAB Holidays ReBaseline | TRAVEL | 2,267.68 | ELOUADRHIRI L | 1 | 1 | LATIFA E | 10-017 | 11-021 | 11-026 |  | 11 -035 |  |  | 13-002F |  |  | 242232185 | E | PE | 13-015 | PR |  |  |  |  | 14-001 |  |  |  |
| 242232546a | Panel 1-b QA and baseline measurements FY14 |  | 98d | 2013-10-01 | 2014-02-28 | 9-130M FS+228d, 242232546 | 453d | 0d | 8/5 M-F w/JLAB Holidays ReBaseline | MECH TECH [132.88 h]; CONTRB UNIV LBR [2126.1 h] | 6,287.94 | ELOUADRHIRI L | 1 | 1 | LATIFA E | 10-017 | 11-021 | 11-026 | 11-032 | 11 -035 | 12-007 |  | 13-002F |  |  | 242232546 | U |  | 13-015 | PR |  |  |  | PE | 14-001 |  |  |  |
| 242232560 | Misc. Repair Parts |  | 77d | 2013-10-23 | 2014-02-21 | 9-140M FS+16d | 458d | 5d | 8/5 M-F w/JLAB Holidays ReBaseline | SUPPLIES & MATERIALS | 5,493.93 | ELOUADRHIRI L | 1 | 1 | LATIFA E | 10-017 | 11-021 | 11-026 |  | 11 -035 |  |  | 13-002F |  |  | 242232560 | D | PE | 13-015 | PR |  |  |  |  | 14-001 |  |  |  |
| 242232232 | Forward carriage patch panels procurement |  | 77d | 2013-10-30 | 2014-02-28 | 9-140M FS+21d | 453d | 0d | 8/5 M-F w/JLAB Holidays ReBaseline | PROCUREMENT<$50K 60; PROCUREMENT>$50K 69 | 5,475.26 | ELOUADRHIRI L | 1 | 1 | LATIFA E | 10-017 | 11-021 | 11-026 | 11-032 | 11 -035 | 12-007 |  | 13-002F |  |  | 242232232 | D |  | 13-015 | PR |  | EJ |  |  | 14-001 | 11-001 | 11-056 |  |
| 242232265a | High Voltage Cable Procurement (Patch Panel Plates/Brackets) |  | 77d | 2013-10-30 | 2014-02-28 | 9-140M FS+21d | 453d | 0d | 8/5 M-F w/JLAB Holidays ReBaseline | PROCUREMENT<$50K 60 | 8,081.02 | ELOUADRHIRI L | 1 | 1 | LATIFA E | 10-017 | 11-021 | 11-026 |  | 11 -035 |  |  | 13-002F |  |  | 242232265a | D |  | 13-015 | PR |  | EJ |  |  | 14-001 |  |  |  |
| 242232396 | Calibration test equipment Procurement |  | 77d | 2013-10-30 | 2014-02-28 | 9-140M FS+21d | 453d | 0d | 8/5 M-F w/JLAB Holidays ReBaseline | PROCUREMENT<$50K 60 | 2,663.97 | ELOUADRHIRI L | 1 | 1 | LATIFA E | 10-017 | 11-021 | 11-026 | 11-032 | 11 -035 | 12-007 |  | 13-002F |  |  | 242232396 | D |  | 13-015 | PR |  | PE |  |  | 14-001 |  | 11-056 |  |
| 242232320S | De-Obligation of USC Contract |  | 1d | 2013-12-20 | 2013-12-20 | 242232320R FS-1d | 456d | 0d | 8/5 M-F w/JLAB Holidays ReBaseline | PROCUREMENT>$50K 69 NO ESCALATION | -46,530.65 | ELOUADRHIRI L | 1 | 1 | LATIFA E | 10-017 | 11-021 | 11-026 |  | 11 -035 |  |  | 13-002F |  |  | 242232320R | D |  | 13-015 | PR |  | OB |  |  |  |  |  |  |
| 242232685M | FTOF Complete | milestone | 0d | 2014-03-03 | 2014-03-03 | 242232655 FS-21d, 242232265a, 242232185, 242232320S, 242232546a, 242232560, 242232396, 242232546, 242232232, 242232320R | 453d | 450d | 8/5 M-F w/JLAB Holidays ReBaseline |  |  | ELOUADRHIRI L | 1 | 1 | LATIFA E | 10-017 | 11-021 | 11-026 | 11-032 | 11 -035 |  | 12-054 | 13-002F |  |  | 242232685M | M |  | 13-015 | PR |  |  |  |  |  |  |  | 13-010 |

| ID | WBS | Activity | Type | Duration | Start | Finish | Predecessors | Total float | Free float | Resources | Cost | RESP - Responsibility | STRT%COMP for CM EVM | FNSH%COMP for CM EVM | Milestone Level | CAM RESPONSIBLE | CR 11-026 | CR 11-035 | CR 12-007 | CR 13-002 | CR 10-001 | Advance Purchase Plan > 500K | CR 10-016 | CR 10-060 | CR 11-001 | CR 12-054 | CR 12-001 |
| --- | --- | --- | --- | --- | --- | --- | --- | --- | --- | --- | --- | --- | --- | --- | --- | --- | --- | --- | --- | --- | --- | --- | --- | --- | --- | --- | --- |
|  | 4 | **1.4.2.2.4 CERENKOV** |  |  | 2009-07-23 | 2015-04-17 |  |  |  |  |  |  |  |  |  |  |  |  |  |  |  |  |  |  |  |  |  |
|  | 1 | **1.4.2.2.4.1 HIGH THRESHOLD CC** |  |  | 2009-07-23 | 2015-04-17 |  |  |  |  |  |  |  |  |  |  |  |  |  |  |  |  |  |  |  |  |  |
| 142241000M |  | HTCC-P-#1 Start Constr | milestone | 0d | 2009-07-23 | 2009-07-23 | 1222241035M, 9-100M FS-60d | 486d | 0d |  |  | ELOUADRHIRI L | 1 | 1 | 6 | LATIFA E | 11-026 | 11 -035 | 12-007 | 13-002F |  |  |  |  |  |  |  |
| 142241002 |  | HTCC-P-#1 Procumnt Prep for Mirror Compnts & Tooling FY09 |  | 49d | 2009-07-23 | 2009-09-30 | 142241000M | 486d | 0d | SCIENTIST [65.33 h] | 4,198.11 | ELOUADRHIRI L | 1 | 1 |  | LATIFA E | 11-026 | 11 -035 | 12-007 | 13-002F | 10-001B |  |  |  |  |  |  |
| 142241002b |  | HTCC-P-#1 Procumnt Prep for Mirror Compnts & Tooling FY10 |  | 11d | 2009-10-01 | 2009-10-15 | 142241002 | 486d | 49d | SCIENTIST [14.67 h] | 972.77 | ELOUADRHIRI L | 1 | 1 |  | LATIFA E | 11-026 | 11 -035 | 12-007 | 13-002F | 10-001B |  |  |  |  |  |  |
| 142241026M |  | HTCC-P-#2 Start Constr | milestone | 0d | 2009-10-01 | 2009-10-01 | 9-100M | 70d | 0d |  |  | ELOUADRHIRI L | 1 | 1 | 6 | LATIFA E | 11-026 | 11 -035 | 12-007 | 13-002F |  |  |  |  |  |  |  |
| 142241102 |  | HTCC-P-#2 Procumnt Prep for Mirror Compnts & Tooling |  | 10d | 2009-10-01 | 2009-10-14 | 142241026M | 70d | 50d | SCIENTIST [40 h] | 2,652.4 | ELOUADRHIRI L | 1 | 1 |  | LATIFA E | 11-026 | 11 -035 | 12-007 | 13-002F |  |  |  |  |  |  |  |
| 142241005 |  | HTCC-P-#1 Vend Manufacturing of Mirror Compnts & Tooling |  | 37d | 2010-01-05 | 2010-02-26 | 142241002b, 9-100M FS+60d | 437d | 0d | SUPPLIES & MATERIALS | 37,809.21 | ELOUADRHIRI L | 1 | 1 |  | LATIFA E | 11-026 | 11 -035 | 12-007 | 13-002F |  | APP | 10-016 |  |  |  |  |
| 142241105 |  | HTCC-P-#2 Vend Manufacturing of Mirror Compnts & Tooling |  | 37d | 2010-01-05 | 2010-02-26 | 9-100M FS+60d, 142241102 | 20d | 0d | SUPPLIES & MATERIALS | 37,809.21 | ELOUADRHIRI L | 1 | 1 |  | LATIFA E | 11-026 | 11 -035 | 12-007 | 13-002F |  | APP | 10-016 |  |  |  |  |
| 142241350M |  | Space required for HTCC construction | milestone | 0d | 2010-03-01 | 2010-03-01 | 9-100M FS+97d | 137d | 0d |  |  | ELOUADRHIRI L | 1 | 1 |  | LATIFA E | 11-026 | 11 -035 | 12-007 | 13-002F |  |  | 10-016 |  |  |  |  |
| 142241465 |  | Procurement Prep for magnetic shields - Lab |  | 26d | 2010-03-31 | 2010-05-05 | 142241210 FS-296d | 521d | 0d | SCIENTIST [40 h] | 2,652.4 | ELOUADRHIRI L | 1 | 1 |  | LATIFA E | 11-026 | 11 -035 | 12-007 | 13-002F |  |  | 10-016 |  |  |  |  |
| 142241360 |  | Transport of all necessary equipment from Test area (room 125, EEL) to the HTCC assembly area |  | 116d | 2010-04-19 | 2010-09-30 | 142241350M FS+35d | 246d | 0d |  |  | ELOUADRHIRI L | 1 | 1 |  | LATIFA E | 11-026 | 11 -035 | 12-007 | 13-002F |  |  | 10-016 |  |  |  |  |
| 142241365 |  | Installation of all equipment for all the HTCC equipment and safety review |  | 116d | 2010-04-19 | 2010-09-30 | 142241360 FS-116d | 246d | 9d |  |  | ELOUADRHIRI L | 1 | 1 |  | LATIFA E | 11-026 | 11 -035 | 12-007 | 13-002F |  |  | 10-016 |  |  |  |  |
| 142241250 |  | Assembly of the mirror #1 substrate - Lab |  | 58d | 2010-04-23 | 2010-07-15 | 142241105 FS+39d | 20d | 0d | SCIENTIST [40 h] | 2,652.4 | ELOUADRHIRI L | 1 | 1 |  | LATIFA E | 11-026 | 11 -035 | 12-007 | 13-002F |  |  | 10-016 |  |  |  |  |
| 142241470 |  | Manufacturing of magnetic shields - Proc |  | 165d | 2010-05-06 | 2011-01-06 | 142241465 | 521d | 0d | PROCUREMENT<$50K 60 NO ESCALATION FY11; PROCUREMENT>$50K 69 NO ESCALATION FY11 | 64,800 | ELOUADRHIRI L | 1 | 1 |  | LATIFA E | 11-026 | 11 -035 | 12-007 | 13-002F |  |  | 10-016 |  |  |  |  |
| 142241355 |  | Procurement of Granite Tables - Proc |  | 94d | 2010-05-28 | 2010-10-11 | 142241350M FS+64d | 137d | 117d | PROCUREMENT<$50K 60 NO ESCALATION FY11 | 10,000 | ELOUADRHIRI L | 1 | 1 |  | LATIFA E | 11-026 | 11 -035 | 12-007 | 13-002F |  |  | 10-016 |  |  |  |  |
| 142241210 |  | Manufacturing of the 5" PMT ET-9823QB and HV dividers - Proc |  | 249d | 2010-06-07 | 2011-06-07 | 142241005 FS+69d | 437d | 0d | PROCUREMENT>$50K 69 NO ESCALATION FY11; PROCUREMENT<$50K 60 NO ESCALATION FY11 | 364,000 | ELOUADRHIRI L | 1 | 1 |  | LATIFA E | 11-026 | 11 -035 | 12-007 | 13-002F |  |  | 10-016 |  |  |  |  |
| 142241354 |  | HTCC Prepare Mezzanine workspace |  | 142d | 2010-07-01 | 2011-01-31 | 9-100M FS+184d | 238d | 1d | PROCUREMENT<$50K 60 NO ESCALATION FY11; PROCUREMENT>$50K 69 NO ESCALATION FY11 | 70,000 | ELOUADRHIRI L | 1 | 1 |  | LATIFA E | 11-026 | 11 -035 | 12-007 | 13-002F |  |  |  | 10-060 |  |  |  |
| 142241475 |  | Tests of up to 10% of magnetic shields - Lab FY10 |  | 58d | 2010-07-12 | 2010-09-30 | 142241470 FS-120d | 521d | 0d | PD UNIV STUDNT [32.91 h]; CONTRB UNIV LBR [16.45 h] | 329.76 | ELOUADRHIRI L | 1 | 1 |  | LATIFA E | 11-026 | 11 -035 | 12-007 | 13-002F |  |  | 10-016 |  | 11-001 |  |  |
| 142241255 |  | Trimming of the mirror #1 substrate -Expenses |  | 5d | 2010-07-16 | 2010-07-22 | 142241250 | 792d |  | MSHOP | 500 | ELOUADRHIRI L | 1 | 1 |  | LATIFA E | 11-026 | 11 -035 | 12-007 | 13-002F |  |  | 10-016 |  |  | 12-054F |  |
| 142241260 |  | Quality control of the mirror #1 substrate - Lab |  | 10d | 2010-07-16 | 2010-07-29 | 142241250 | 20d | 0d | SCIENTIST [40 h] | 2,652.4 | ELOUADRHIRI L | 1 | 1 |  | LATIFA E | 11-026 | 11 -035 | 12-007 | 13-002F |  |  | 10-016 |  |  |  |  |
| 142241265 |  | Tooling manufacturing for mirror segments construction - Lab |  | 16d | 2010-07-29 | 2010-08-19 | 142241260 FS-1d | 20d | 0d | SCIENTIST [80 h]; MECH DES [40 h] | 7,114.4 | ELOUADRHIRI L | 1 | 1 |  | LATIFA E | 11-026 | 11 -035 | 12-007 | 13-002F |  |  | 10-016 |  |  |  |  |
| 142241310 |  | Procurement Prep of ROHACELL foam sheets for substrates manufacturing - Lab |  | 11d | 2010-07-29 | 2010-08-12 | 142241260 FS-1d | 590d | 0d | SCIENTIST [20 h] | 1,326.2 | ELOUADRHIRI L | 1 | 1 |  | LATIFA E | 11-026 | 11 -035 | 12-007 | 13-002F |  |  | 10-016 |  |  |  |  |
| 142241320 |  | Procurement Prep of plastic monomers (acrylic and / or epoxy with low vapor pressure) - Lab |  | 11d | 2010-07-29 | 2010-08-12 | 142241260 FS-1d | 237d | 0d | SCIENTIST [20 h] | 1,326.2 | ELOUADRHIRI L | 1 | 1 |  | LATIFA E | 11-026 | 11 -035 | 12-007 | 13-002F |  |  | 10-016 |  |  |  |  |
| 142241330 |  | Procurement prep of plastic films/sheets of optical quality - Lab |  | 11d | 2010-07-29 | 2010-08-12 | 142241260 FS-1d | 590d | 0d | SCIENTIST [10 h] | 663.1 | ELOUADRHIRI L | 1 | 1 |  | LATIFA E | 11-026 | 11 -035 | 12-007 | 13-002F |  |  | 10-016 |  |  |  |  |
| 142241270 |  | Manufacturing of tooling for mirror segments construction - Expenses FY10 |  | 44d | 2010-07-30 | 2010-09-30 | 142241265 FS-15d | 228d | 0d | MSHOP | 14,044.07 | ELOUADRHIRI L | 1 | 1 |  | LATIFA E | 11-026 | 11 -035 | 12-007 | 13-002F |  |  | 10-016 |  | 11-001 |  |  |
| 142241275 |  | Quality Control of tooling for mirror segments construction - Lab FY10 |  | 44d | 2010-07-30 | 2010-09-30 | 142241265 FS-15d | 619.5d | 0d | SCIENTIST [33.85 h] | 2,244.59 | ELOUADRHIRI L | 1 | 1 |  | LATIFA E | 11-026 | 11 -035 | 12-007 | 13-002F |  |  | 10-016 |  | 11-001 |  |  |
| 142241430M |  | Start Manufacturing of the Containment Vessel | milestone | 0d | 2010-08-02 | 2010-08-02 | 9-100M FS+205d | 259d | 0d |  |  | ELOUADRHIRI L | 1 | 1 |  | LATIFA E | 11-026 | 11 -035 | 12-007 | 13-002F |  |  | 10-016 |  |  | 12-054F |  |
| 142241435 |  | Procurement prep of CV construction parts - Lab FY10 |  | 43d | 2010-08-02 | 2010-09-30 | 142241430M | 259d | 0d | SCIENTIST [11.39 h]; MECH ENG [11.39 h]; MECH DES [11.39 h] | 2,020.58 | ELOUADRHIRI L | 1 | 1 |  | LATIFA E | 11-026 | 11 -035 | 12-007 | 13-002F |  |  | 10-016 |  | 11-001 | 12-054F |  |
| 142241495 |  | Procurement prep of cables and gas systems - Lab FY10 |  | 43d | 2010-08-02 | 2010-09-30 | 9-100M FS+205d | 505d | 0d | SCIENTIST [38.22 h]; MECH TECH [76.44 h] | 5,724.98 | ELOUADRHIRI L | 1 | 1 |  | LATIFA E | 11-026 | 11 -035 | 12-007 | 13-002F |  |  | 10-016 |  | 11-001 |  |  |
| 142241315 |  | Procurement of ROHACELL foam sheets for substrates manufacturing - Proc |  | 34d | 2010-08-13 | 2010-09-30 | 142241310 | 590d | 0d | PROCUREMENT<$50K 60 | 4,200 | ELOUADRHIRI L | 1 | 1 |  | LATIFA E | 11-026 | 11 -035 | 12-007 | 13-002F |  |  | 10-016 |  |  |  |  |
| 142241325 |  | Procurement of plastic monomers (acrylic and / or epoxy with low vapor pressure) - Proc |  | 34d | 2010-08-13 | 2010-09-30 | 142241320 | 237d | 0d | PROCUREMENT<$50K 60 | 500 | ELOUADRHIRI L | 1 | 1 |  | LATIFA E | 11-026 | 11 -035 | 12-007 | 13-002F |  |  | 10-016 |  |  |  |  |
| 142241335 |  | Procurement of plastic films/sheets of optical quality - Proc |  | 34d | 2010-08-13 | 2010-09-30 | 142241330 | 590d | 0d | PROCUREMENT<$50K 60 | 2,200 | ELOUADRHIRI L | 1 | 1 |  | LATIFA E | 11-026 | 11 -035 | 12-007 | 13-002F |  |  | 10-016 |  |  |  |  |
| 142241280 |  | Tooling manufacturing for mirror half-sectors assembly - Lab FY10 |  | 10d | 2010-09-17 | 2010-09-30 | 142241265 FS+19d | 20d | 0d | SCIENTIST [33.33 h]; MECH DES [16.67 h]; MECH ENG [16.67 h] | 4,061.98 | ELOUADRHIRI L | 1 | 1 |  | LATIFA E | 11-026 | 11 -035 | 12-007 | 13-002F |  |  | 10-016 |  | 11-001 |  |  |
| 142241340 |  | Manufacturing of foam mirror substrates - Expenses FY10 |  | 1d | 2010-09-30 | 2010-09-30 | 142241275a FS-51.5d, 142241335 FS-1d, 142241315 FS-1d | 590d | 0d | MSHOP | 779.22 | ELOUADRHIRI L | 1 | 1 |  | LATIFA E | 11-026 | 11 -035 | 12-007 | 13-002F |  |  | 10-016 |  | 11-001 |  |  |
| 142241345 |  | Quality control of cut mirror substrates - Lab FY10 |  | 1d | 2010-09-30 | 2010-09-30 | 142241340a FS-154d | 590d | 0d | SCIENTIST [0.39 h] | 25.86 | ELOUADRHIRI L | 1 | 1 |  | LATIFA E | 11-026 | 11 -035 | 12-007 | 13-002F |  |  | 10-016 |  | 11-001 |  |  |
| 142241270a |  | Manufacturing of tooling for mirror segments construction - Expenses FY11 |  | 20d | 2010-10-01 | 2010-10-28 | 142241270 | 228d | 0d | MSHOP | 6,587.31 | ELOUADRHIRI L | 1 | 1 |  | LATIFA E | 11-026 | 11 -035 | 12-007 | 13-002F |  |  | 10-016 |  | 11-001 |  |  |
| 142241275a |  | Quality Control of tooling for mirror segments construction - Lab FY11 |  | 21d | 2010-10-01 | 2010-10-29 | 142241275 | 619.5d | 29.5d | SCIENTIST [16.15 h] | 1,105.14 | ELOUADRHIRI L | 1 | 1 |  | LATIFA E | 11-026 | 11 -035 | 12-007 | 13-002F |  |  | 10-016 |  | 11-001 |  |  |
| 142241280a |  | Tooling manufacturing for mirror half-sectors assembly - Lab FY11 |  | 14d | 2010-10-01 | 2010-10-20 | 142241280 | 20d | 0d | SCIENTIST [46.67 h]; MECH DES [23.33 h]; MECH ENG [23.33 h] | 5,867.94 | ELOUADRHIRI L | 1 | 1 |  | LATIFA E | 11-026 | 11 -035 | 12-007 | 13-002F |  |  | 10-016 |  | 11-001 |  |  |
| 142241340a |  | Manufacturing of foam mirror substrates - Expenses FY11 |  | 153d | 2010-10-01 | 2011-05-17 | 142241340 | 590d | 0d | MSHOP | 123,023.92 | ELOUADRHIRI L | 1 | 1 |  | LATIFA E | 11-026 | 11 -035 | 12-007 | 13-002F |  |  | 10-016 |  | 11-001 |  |  |
| 142241345a |  | Quality control of cut mirror substrates - Lab FY11 |  | 153d | 2010-10-01 | 2011-05-17 | 142241345 | 590d |  | SCIENTIST [59.61 h] | 4,079.11 | ELOUADRHIRI L | 1 | 1 |  | LATIFA E | 11-026 | 11 -035 | 12-007 | 13-002F |  |  | 10-016 |  | 11-001 |  |  |
| 142241435a |  | Procurement prep of CV construction parts - Lab FY11 |  | 108d | 2010-10-01 | 2011-03-15 | 142241435 | 259d | 210d | MECH ENG [28.61 h]; SCIENTIST [28.61 h]; MECH DES [28.61 h] | 5,237.34 | ELOUADRHIRI L | 1 | 1 |  | LATIFA E | 11-026 | 11 -035 | 12-007 | 13-002F |  |  | 10-016 |  | 11-001 | 12-054F |  |
| 142241475a |  | Tests of up to 10% of magnetic shields - Lab FY11 |  | 83d | 2010-10-01 | 2011-02-07 | 142241475 | 521d | 469d | CONTRB UNIV LBR [23.55 h]; PD UNIV STUDNT [47.09 h] | 486.91 | ELOUADRHIRI L | 1 | 1 |  | LATIFA E | 11-026 | 11 -035 | 12-007 | 13-002F |  |  | 10-016 |  | 11-001 |  |  |
| 142241495a |  | Procurement prep of cables and gas systems - Lab FY11 |  | 2d | 2010-10-01 | 2010-10-04 | 142241495 | 505d | 0d | SCIENTIST [1.78 h]; MECH TECH [3.56 h] | 275.14 | ELOUADRHIRI L | 1 | 1 |  | LATIFA E | 11-026 | 11 -035 | 12-007 | 13-002F |  |  | 10-016 |  | 11-001 |  |  |
| 142241500 |  | Manufacturing of high voltage (HV) cable RG8X - Proc |  | 97d | 2010-10-05 | 2011-03-02 | 142241495a | 505d | 453d | PROCUREMENT<$50K 60 | 3,054.42 | ELOUADRHIRI L | 1 | 1 |  | LATIFA E | 11-026 | 11 -035 | 12-007 | 13-002F |  |  | 10-016 |  |  |  |  |
| 142241505 |  | Manufacturing of signal cable PE-B319 - Proc |  | 97d | 2010-10-05 | 2011-03-02 | 142241495a | 505d | 453d | PROCUREMENT<$50K 60 | 8,193.29 | ELOUADRHIRI L | 1 | 1 |  | LATIFA E | 11-026 | 11 -035 | 12-007 | 13-002F |  |  | 10-016 |  |  |  |  |
| 142241510 |  | Manufacturing of HV connectors PE-4193 - Proc |  | 97d | 2010-10-05 | 2011-03-02 | 142241495a | 505d | 453d | PROCUREMENT<$50K 60 | 532.46 | ELOUADRHIRI L | 1 | 1 |  | LATIFA E | 11-026 | 11 -035 | 12-007 | 13-002F |  |  | 10-016 |  |  |  |  |
| 142241515 |  | Manufacturing of HV connectors PE-4493 - Proc |  | 97d | 2010-10-05 | 2011-03-02 | 142241495a | 505d | 453d | PROCUREMENT<$50K 60 | 1,652.07 | ELOUADRHIRI L | 1 | 1 |  | LATIFA E | 11-026 | 11 -035 | 12-007 | 13-002F |  |  | 10-016 |  |  |  |  |
| 142241520 |  | Manufacturing of BNC connectors PE-4386 - Proc |  | 97d | 2010-10-05 | 2011-03-02 | 142241495a | 505d | 453d | PROCUREMENT<$50K 60 | 824.49 | ELOUADRHIRI L | 1 | 1 |  | LATIFA E | 11-026 | 11 -035 | 12-007 | 13-002F |  |  | 10-016 |  |  |  |  |
| 142241525 |  | Manufacturing of BNC connectors PE-4014 - Proc |  | 97d | 2010-10-05 | 2011-03-02 | 142241495a | 505d | 453d | PROCUREMENT<$50K 60 | 176.45 | ELOUADRHIRI L | 1 | 1 |  | LATIFA E | 11-026 | 11 -035 | 12-007 | 13-002F |  |  | 10-016 |  |  |  |  |
| 142241530 |  | Manufacturing of Pump EW-07061-42 - Proc |  | 97d | 2010-10-05 | 2011-03-02 | 142241495a | 644d |  | PROCUREMENT<$50K 60 | 410.7 | ELOUADRHIRI L | 1 | 1 |  | LATIFA E | 11-026 | 11 -035 | 12-007 | 13-002F |  |  | 10-016 |  |  |  |  |
| 142241535 |  | Manufacturing of Power Supply S-240-15 - Proc |  | 97d | 2010-10-05 | 2011-03-02 | 142241495a | 644d |  | PROCUREMENT<$50K 60 | 95.97 | ELOUADRHIRI L | 1 | 1 |  | LATIFA E | 11-026 | 11 -035 |  | 13-002F |  |  | 10-016 |  |  |  |  |
| 142241540 |  | Manufacturing of Controller 250E-4-D - Proc |  | 97d | 2010-10-05 | 2011-03-02 | 142241495a | 644d |  | PROCUREMENT<$50K 60 | 2,575.62 | ELOUADRHIRI L | 1 | 1 |  | LATIFA E | 11-026 | 11 -035 |  | 13-002F |  |  | 10-016 |  |  |  |  |
| 142241545 |  | Manufacturing of Transformer FF-108U Proc |  | 97d | 2010-10-05 | 2011-03-02 | 142241495a | 644d |  | PROCUREMENT<$50K 60 | 29.93 | ELOUADRHIRI L | 1 | 1 |  | LATIFA E | 11-026 | 11 -035 |  | 13-002F |  |  | 10-016 |  |  |  |  |
| 142241550 |  | Manufacturing of Utility Chasis CHA-5X21 - Proc |  | 97d | 2010-10-05 | 2011-03-02 | 142241495a | 644d |  | PROCUREMENT<$50K 60 | 275.52 | ELOUADRHIRI L | 1 | 1 |  | LATIFA E | 11-026 | 11 -035 |  | 13-002F |  |  | 10-016 |  |  |  |  |
| 142241555 |  | Manufacturing of Controller DP25B-EAR - Proc |  | 97d | 2010-10-05 | 2011-03-02 | 142241495a | 644d |  | PROCUREMENT<$50K 60 | 407.6 | ELOUADRHIRI L | 1 | 1 |  | LATIFA E | 11-026 | 11 -035 |  | 13-002F |  |  | 10-016 |  |  |  |  |
| 142241560 |  | Manufacturing of Cable 1255/8BK002 - Proc |  | 97d | 2010-10-05 | 2011-03-02 | 142241495a | 644d |  | PROCUREMENT<$50K 60 | 2,031.81 | ELOUADRHIRI L | 1 | 1 |  | LATIFA E | 11-026 | 11 -035 |  | 13-002F |  |  | 10-016 |  |  |  |  |
| 142241565 |  | Procurement of 1/2 Stainless Steel Tubing - Proc |  | 97d | 2010-10-05 | 2011-03-02 | 142241495a | 644d |  | PROCUREMENT<$50K 60 | 1,362.11 | ELOUADRHIRI L | 1 | 1 |  | LATIFA E | 11-026 | 11 -035 |  | 13-002F |  |  | 10-016 |  |  |  |  |
| 142241370 |  | Assembly of 12 indentical sets and QA of 5 substrates (60 substrates total) - Lab FY11 |  | 239d | 2010-10-14 | 2011-09-30 | 142241354 FS-70d, 142241325 FS+9d, 142241365, 142241270a FS-40d | 237d | 0d | MECH ENG [15.62 h]; VISTNG USERS [1099.71 h]; SCIENTIST [328.04 h]; MECH TECH [999.74 h] | 87,165.53 | ELOUADRHIRI L | 1 | 1 |  | LATIFA E | 11-026 | 11 -035 | 12-007 | 13-002F |  |  | 10-016 |  |  |  | 12-001 |
| 142241375 |  | Tests of assembled substrates - Lab FY11 |  | 239d | 2010-10-14 | 2011-09-30 | 142241270a FS-11d, 142241365 FS-10d | 418d | 0d | MECH TECH [30.25 h]; SCIENTIST [30.25 h]; VISTNG USERS [151.27 h] | 6,206.17 | ELOUADRHIRI L | 1 | 1 |  | LATIFA E | 11-026 | 11 -035 | 12-007 | 13-002F |  |  | 10-016 |  |  |  | 12-001 |
| 142241285 |  | Manufacturing of tooling for mirror half sectors assembly - Expenses |  | 100d | 2010-10-21 | 2011-03-23 | 142241280a | 30d | 10d | MSHOP | 22,289.04 | ELOUADRHIRI L | 1 | 1 |  | LATIFA E | 11-026 | 11 -035 | 12-007 | 13-002F |  |  | 10-016 |  |  |  |  |
| 142241290 |  | Quality Control of tooling for mirror half-sectors assembly - Lab |  | 110d | 2010-10-21 | 2011-04-06 | 142241280a | 20d | 0d | SCIENTIST [45 h] | 3,079.35 | ELOUADRHIRI L | 1 | 1 |  | LATIFA E | 11-026 | 11 -035 | 12-007 | 13-002F |  |  | 10-016 |  |  |  |  |
| 142241380 |  | Precision trimming of 12 identical sets of 5 substrates (60 substrates total) - Expenses FY11 |  | 222d | 2010-11-08 | 2011-09-30 | 142241365, 142241270a FS+6d | 228d | 0d | MSHOP | 14,710.27 | ELOUADRHIRI L | 1 | 1 |  | LATIFA E | 11-026 | 11 -035 | 12-007 | 13-002F |  |  | 10-016 |  |  |  | 12-001 |
| 142241385 |  | Quality control of trimmed substrates before deposition of coating - Labor FY11 |  | 221d | 2010-11-09 | 2011-09-30 | 142241370a FS-415d, 142241365, 142241270a FS+7d, 142241380a FS-447.5d | 353d | 0d | SCIENTIST [25.85 h]; MECH ENG [25.85 h] | 3,525.43 | ELOUADRHIRI L | 1 | 1 |  | LATIFA E | 11-026 | 11 -035 | 12-007 | 13-002F |  |  | 10-016 |  |  | 12-054F | 12-001 |
| 142241395 |  | Quality control of 60 coated substrates - Lab FY11 |  | 217d | 2010-11-15 | 2011-09-30 | 9-110M FS+31d | 353d | 0d | SCIENTIST [24.18 h] | 1,654.64 | ELOUADRHIRI L | 1 | 1 |  | LATIFA E | 11-026 | 11 -035 | 12-007 | 13-002F |  |  | 10-016 |  |  |  | 12-001 |
| 142241480 |  | Procurement Prep of Light Collectors (WC) - Lab |  | 23d | 2010-11-24 | 2011-01-05 | 9-110M FS+38d | 317d | 0d | SCIENTIST [16 h]; CONTRB UNIV LBR [80 h] | 1,094.88 | ELOUADRHIRI L | 1 | 1 |  | LATIFA E | 11-026 | 11 -035 | 12-007 | 13-002F |  |  | 10-016 |  |  |  |  |
| 142241400 |  | Tests for coated substrates - Lab FY11 |  | 207d | 2010-12-01 | 2011-09-30 | 142241385a FS-328d | 353d | 0d | MECH TECH [23.73 h]; PD UNIV STUDNT [94.9 h]; CONTRB UNIV LBR [213.53 h]; SCIENTIST [23.73 h] | 3,627.16 | ELOUADRHIRI L | 1 | 1 |  | LATIFA E | 11-026 | 11 -035 | 12-007 | 13-002F |  |  | 10-016 |  |  |  | 12-001 |
| 142241485 |  | Manufacturing of Light Collectors (WC) - Proc |  | 204d | 2011-01-06 | 2011-10-25 | 142241480 | 317d | 0d | PROCUREMENT<$50K 60 NO ESCALATION FY12 | 23,836.89 | ELOUADRHIRI L | 1 | 1 |  | LATIFA E | 11-026 | 11 -035 | 12-007 | 13-002F |  |  | 10-016 |  |  |  |  |
| 142241490 |  | Quality control of Light Collectors (WC) - Lab |  | 194d | 2011-02-23 | 2011-11-28 | 142241487 FS-366d, 142241485 FS-172d | 317d | 265d | CONTRB UNIV LBR [120 h] |  | ELOUADRHIRI L | 1 | 1 |  | LATIFA E | 11-026 | 11 -035 | 12-007 | 13-002F |  |  | 10-016 |  |  |  |  |
| 142241295 |  | Tooling manufacturing for combined mirror assembly - Lab |  | 93d | 2011-04-07 | 2011-08-17 | 142241290 | 482d | 0d | SCIENTIST [80 h]; MECH ENG [80 h]; MECH DES [80 h] | 14,644.8 | ELOUADRHIRI L | 1 | 1 |  | LATIFA E | 11-026 | 11 -035 | 12-007 | 13-002F |  |  | 10-016 |  |  |  |  |

| ID | Activity | Duration | Start | Finish | Predecessors | Total float | Free float | Calendar | Resources | Cost | RESP - Responsibility | STRT%COMP for CM EVM | FNSH%COMP for CM EVM | CAM RESPONSIBLE | CR 10-016 | CR 11-026 | CR 11-035 | CR 12-001 | CR 12-007 | CR 13-002 | CR 12-054 | CR 11-001 | CR 12-053 | CR 12-055 | CR 13-014 | CR 12-027 | ReBaseline Actuals Adjustment | Original Activity ID Rebaseline | EVMS Reporting Codes | BOE Labor | CR 13-015 | Post Rebaseline | BOE Expenses | Over Under Fixed | BOE Procurement | Obligated Prior to Rebaseline | Activities with Steps | CR 14-001 |
| --- | --- | --- | --- | --- | --- | --- | --- | --- | --- | --- | --- | --- | --- | --- | --- | --- | --- | --- | --- | --- | --- | --- | --- | --- | --- | --- | --- | --- | --- | --- | --- | --- | --- | --- | --- | --- | --- | --- |
| 142241405 | Dry Fit of Preformed Mirror facets into rings - Lab FY11 | 124d | 2011-04-07 | 2011-09-30 | 142241290, 142241355, 142241285 | 20d | 0d |  | MECH DES [15.95 h]; MECH TECH [382.77 h]; VISTNG USERS [478.46 h]; SCIENTIST [139.55 h] | 35,741.42 | ELOUADRHIRI L | 1 | 1 | LATIFA E | 10-016 | 11-026 | 11 -035 | 12-001 | 12-007 | 13-002F |  |  |  |  |  |  |  |  |  |  |  |  |  |  |  |  |  |  |
| 142241410 | Quality control of assembled mirror half-sectors - Lab FY11 | 93d | 2011-05-20 | 2011-09-30 | 142241405a FS-114d | 474d | 0d |  | PD UNIV STUDNT [24.72 h]; CONTRB UNIV LBR [24.72 h]; SCIENTIST [30.9 h]; MECH ENG [12.36 h] | 3,209.95 | ELOUADRHIRI L | 1 | 1 | LATIFA E | 10-016 | 11-026 | 11 -035 | 12-001 | 12-007 | 13-002F |  |  |  |  |  |  |  |  |  |  |  |  |  |  |  |  |  |  |
| 142241415 | Checks of geometry of mirror half-sectors - Lab FY11 | 93d | 2011-05-20 | 2011-09-30 | 142241405a FS-114d | 474d | 0d |  | CONTRB UNIV LBR [23.03 h]; SCIENTIST [46.07 h]; PD UNIV STUDNT [23.03 h] | 3,390.7 | ELOUADRHIRI L | 1 | 1 | LATIFA E | 10-016 | 11-026 | 11 -035 | 12-001 | 12-007 | 13-002F |  |  |  |  |  |  |  |  |  |  |  |  |  |  |  |  |  |  |
| 142241570 | Procurement Prep of the composite exit window - Lab | 45d | 2011-07-01 | 2011-09-02 | 9-110M FS+184d | 106d | 0d |  | SCIENTIST [360 h] | 24,634.8 | ELOUADRHIRI L | 1 | 1 | LATIFA E | 10-016 | 11-026 | 11 -035 |  | 12-007 | 13-002F |  |  |  |  |  |  |  |  |  |  |  |  |  |  |  |  |  |  |
| 142241300 | Manufacturing of tooling for combined mirror assembly - Expenses FY11 | 31d | 2011-08-18 | 2011-09-30 | 142241295 | 500.5d | 0d |  | MSHOP | 22,317.83 | ELOUADRHIRI L | 1 | 1 | LATIFA E | 10-016 | 11-026 | 11 -035 | 12-001 | 12-007 | 13-002F |  |  |  |  |  |  |  |  |  |  |  |  |  |  |  |  |  |  |
| 142241305 | Quality Control of tooling for combined mirror assembly - Lab FY11 | 31d | 2011-08-18 | 2011-09-30 | 142241295, 142241300a FS-61.5d | 482d | 0d |  | SCIENTIST [42.27 h] | 2,892.54 | ELOUADRHIRI L | 1 | 1 | LATIFA E | 10-016 | 11-026 | 11 -035 | 12-001 | 12-007 | 13-002F |  |  |  |  |  |  |  |  |  |  |  |  |  |  |  |  |  |  |
| 142241450 | Assembly of the CV - Lab FY11 | 12d | 2011-09-15 | 2011-09-30 | 142241440a FS-423d, 142241445a FS-423d, 142241440 FS-423d | 316d | 0d |  | MECH TECH [19.51 h]; VISTNG USERS [9.75 h]; SCIENTIST [4.88 h] | 1,356.86 | ELOUADRHIRI L | 1 | 1 | LATIFA E | 10-016 | 11-026 | 11 -035 | 12-001 | 12-007 | 13-002F |  |  |  |  |  |  |  |  |  |  |  |  |  |  |  |  |  |  |
| 142241300a | Manufacturing of tooling for combined mirror assembly - Expenses FY12 | 12d | 2011-10-03 | 2011-10-18 | 142241300 | 500.5d | 18.5d |  | MSHOP | 8,914.76 | ELOUADRHIRI L | 1 | 1 | LATIFA E | 10-016 | 11-026 | 11 -035 | 12-001 | 12-007 | 13-002F |  |  |  |  |  |  |  |  |  |  |  |  |  |  |  |  |  |  |
| 142241305a | Quality Control of tooling for combined mirror assembly - Lab FY12 | 13d | 2011-10-03 | 2011-10-19 | 142241305 | 482d |  |  | SCIENTIST [17.73 h] | 1,251.92 | ELOUADRHIRI L | 1 | 1 | LATIFA E | 10-016 | 11-026 | 11 -035 | 12-001 | 12-007 | 13-002F |  |  |  |  |  |  |  |  |  |  |  |  |  |  |  |  |  |  |
| 142241370a | Assembly of 12 indentical sets and QA of 5 substrates (60 substrates total) - Lab FY12 | 21d | 2011-10-03 | 2011-10-31 | 142241370 | 237d | 0d |  | MECH ENG [1.37 h]; MECH TECH [87.84 h]; VISTNG USERS [96.63 h]; SCIENTIST [28.82 h] | 7,902.77 | ELOUADRHIRI L | 1 | 1 | LATIFA E | 10-016 | 11-026 | 11 -035 | 12-001 | 12-007 | 13-002F |  |  |  |  |  |  |  |  |  |  |  |  |  |  |  |  |  |  |
| 142241375a | Tests of assembled substrates - Lab FY12 | 77d | 2011-10-03 | 2012-01-30 | 142241375 | 418d |  |  | SCIENTIST [9.75 h]; VISTNG USERS [48.73 h]; MECH TECH [9.75 h] | 2,063.69 | ELOUADRHIRI L | 1 | 1 | LATIFA E | 10-016 | 11-026 | 11 -035 | 12-001 | 12-007 | 13-002F |  |  |  |  |  |  |  |  |  |  |  |  |  |  |  |  |  |  |
| 142241380a | Precision trimming of 12 identical sets of 5 substrates (60 substrates total) - Expenses FY12 | 77d | 2011-10-03 | 2012-01-30 | 142241380 | 228d | 0d |  | MSHOP | 5,264.97 | ELOUADRHIRI L | 1 | 1 | LATIFA E | 10-016 | 11-026 | 11 -035 | 12-001 | 12-007 | 13-002F |  |  |  |  |  |  |  |  |  |  |  |  |  |  |  |  |  |  |
| 142241385a | Quality control of trimmed substrates before deposition of coating - Labor FY12 | 121d | 2011-10-03 | 2012-04-02 | 142241385 | 353d | 0d |  | SCIENTIST [14.15 h]; MECH ENG [14.15 h] | 1,991.33 | ELOUADRHIRI L | 1 | 1 | LATIFA E | 10-016 | 11-026 | 11 -035 | 12-001 | 12-007 | 13-002F | 12-054F |  |  |  |  |  |  |  |  |  |  |  |  |  |  |  |  |  |
| 142241395a | Quality control of 60 coated substrates - Lab FY12 | 142d | 2011-10-03 | 2012-05-01 | 142241395 | 353d |  |  | SCIENTIST [15.82 h] | 1,117.05 | ELOUADRHIRI L | 1 | 1 | LATIFA E | 10-016 | 11-026 | 11 -035 | 12-001 | 12-007 | 13-002F |  |  |  |  |  |  |  |  |  |  |  |  |  |  |  |  |  |  |
| 142241400a | Tests for coated substrates - Lab FY12 | 142d | 2011-10-03 | 2012-05-01 | 142241400 | 353d |  |  | MECH TECH [16.27 h]; PD UNIV STUDNT [65.1 h]; CONTRB UNIV LBR [146.47 h]; SCIENTIST [16.27 h] | 2,566.48 | ELOUADRHIRI L | 1 | 1 | LATIFA E | 10-016 | 11-026 | 11 -035 | 12-001 | 12-007 | 13-002F |  |  |  |  |  |  |  |  |  |  |  |  |  |  |  |  |  |  |
| 142241405a | Dry Fit of Preformed Mirror facets into rings - Lab FY12 | 21d | 2011-10-03 | 2011-10-31 | 142241405 | 20d | 0d |  | SCIENTIST [23.63 h]; MECH DES [2.7 h]; MECH TECH [64.82 h]; VISTNG USERS [81.03 h] | 6,245.65 | ELOUADRHIRI L | 1 | 1 | LATIFA E | 10-016 | 11-026 | 11 -035 | 12-001 | 12-007 | 13-002F |  |  |  |  |  |  |  |  |  |  |  |  |  |  |  |  |  |  |
| 142241410a | Quality control of assembled mirror half-sectors - Lab FY12 | 21d | 2011-10-03 | 2011-10-31 | 142241410 | 474d |  |  | MECH ENG [2.79 h]; PD UNIV STUDNT [5.58 h]; CONTRB UNIV LBR [5.58 h]; SCIENTIST [6.98 h] | 747.85 | ELOUADRHIRI L | 1 | 1 | LATIFA E | 10-016 | 11-026 | 11 -035 | 12-001 | 12-007 | 13-002F |  |  |  |  |  |  |  |  |  |  |  |  |  |  |  |  |  |  |
| 142241415a | Checks of geometry of mirror half-sectors - Lab FY12 | 21d | 2011-10-03 | 2011-10-31 | 142241415 | 474d |  |  | CONTRB UNIV LBR [5.2 h]; SCIENTIST [10.4 h]; PD UNIV STUDNT [5.2 h] | 789.79 | ELOUADRHIRI L | 1 | 1 | LATIFA E | 10-016 | 11-026 | 11 -035 | 12-001 | 12-007 | 13-002F |  |  |  |  |  |  |  |  |  |  |  |  |  |  |  |  |  |  |
| 142241450a | Assembly of the CV - Lab FY12 | 21d | 2011-10-03 | 2011-10-31 | 142241450 | 316d | 296d |  | MECH TECH [34.12 h]; VISTNG USERS [17.06 h]; SCIENTIST [8.53 h] | 2,448.35 | ELOUADRHIRI L | 1 | 1 | LATIFA E | 10-016 | 11-026 | 11 -035 | 12-001 | 12-007 | 13-002F |  |  |  |  |  |  |  |  |  |  |  |  |  |  |  |  |  |  |
| 142241270b | Manufacturing of tooling for mirror segments construction - Expenses FY12 | 110d | 2011-11-01 | 2012-04-16 | 9-120M FS+21d | 234d | 6d |  | MSHOP | 47,500 | ELOUADRHIRI L | 1 | 1 | LATIFA E | 10-016 | 11-026 | 11 -035 |  | 12-007 | 13-002F |  | 11-001 |  |  |  |  |  |  |  |  |  |  |  |  |  |  |  |  |
| 142241370b | Assembly of 12 indentical sets and QA of 5 substrates (60 substrates total) - Revised Lab FY12 | 207d | 2011-11-01 | 2012-08-31 | 142241370a | 237d | 9d |  | MECH ENG [3.01 h]; MECH TECH [2480 h]; VISTNG USERS [211.66 h]; SCIENTIST [560 h] | 154,055.25 | ELOUADRHIRI L | 1 | 1 | LATIFA E | 10-016 | 11-026 | 11 -035 | 12-001 | 12-007 | 13-002F |  |  |  |  |  |  |  |  |  |  |  |  |  |  |  |  |  |  |
| 142241647 | Proc. Prep of components for the HTCC Light Monitoring System | 28d | 2011-11-01 | 2011-12-12 | 9-120M FS+21d | 208d | 188d |  | MECH ENG [80 h] | 5,609.6 | ELOUADRHIRI L | 1 | 1 | LATIFA E | 10-016 | 11-026 | 11 -035 |  | 12-007 | 13-002F |  |  |  |  |  |  |  |  |  |  |  |  |  |  |  |  |  |  |
| 142241487 | Manufacturing of Additional Light Collectors (WC) - Proc | 161d | 2011-11-02 | 2012-06-29 | 142241485 FS+5d | 345d | 28d |  | PROCUREMENT<$50K 60 | 32,750 | ELOUADRHIRI L | 1 | 1 | LATIFA E | 10-016 | 11-026 | 11 -035 |  | 12-007 | 13-002F |  |  |  |  |  |  |  |  |  |  |  |  |  |  |  |  |  |  |
| 142241302 | Procurement of Lab Equipment for Clean Rooms | 61d | 2012-01-05 | 2012-04-02 | 9-120M FS+60d | 374d |  |  | PROCUREMENT<$50K 60 | 31,000 | ELOUADRHIRI L | 1 | 1 | LATIFA E | 10-016 | 11-026 | 11 -035 |  | 12-007 | 13-002F |  |  |  |  |  |  |  |  |  |  |  |  |  |  |  |  |  |  |
| 142241445 | Manufacturing of Central Dish for the containment vessel FY12 | 176d | 2012-01-23 | 2012-09-28 | 9-120M FS+71d, 142241435a FS+1d | 49d | 0d |  | MSHOP | 31,058.8 | ELOUADRHIRI L | 1 | 1 | LATIFA E | 10-016 | 11-026 | 11 -035 |  | 12-007 | 13-002F | 12-054F |  | 12-053 |  |  |  |  |  |  |  |  |  |  |  |  |  |  |  |
| 142241382 | Precision trimming of 12 identical sets of 5 substrates (60 substrates total) - Additional Expenses FY12 | 170d | 2012-01-31 | 2012-09-28 | 142241270b FS-60d, 142241380a, 142241370b FS-160d | 228d | 0d |  | MSHOP | 5,983.56 | ELOUADRHIRI L | 1 | 1 | LATIFA E | 10-016 | 11-026 | 11 -035 |  | 12-007 | 13-002F |  |  | 12-053 |  |  |  |  |  |  |  |  |  |  |  |  |  |  |  |
| 142241300b | Purchase of Pumps and Plumbing for Combined Mirror Assembly | 61d | 2012-02-03 | 2012-04-30 | 9-120M FS+80d | 21d | 1d |  | PROCUREMENT<$50K 60 | 38,000 | ELOUADRHIRI L | 1 | 1 | LATIFA E | 10-016 | 11-026 | 11 -035 |  | 12-007 | 13-002F |  |  |  |  |  |  |  |  |  |  |  |  |  |  |  |  |  |  |
| 142241527 | Procurement of components for the HTCC Gas System construction | 395d | 2012-02-03 | 2013-08-30 | 9-120M FS+80d | 20d |  |  | PROCUREMENT<$50K 60 NO ESCALATION FY13 | 20,000 | ELOUADRHIRI L | 1 | 1 | LATIFA E | 10-016 | 11-026 | 11 -035 |  | 12-007 | 13-002F |  |  |  |  |  |  |  |  |  |  |  |  |  |  |  |  |  |  |
| 142241440 | Manufacturing of parts for the CV construction - Proc Part A | 302d | 2012-03-12 | 2013-05-24 | 9-120M FS+105d, 142241435a | 20d | 0d |  | PROCUREMENT<$50K 60 NO ESCALATION FY13 | 10,000 | ELOUADRHIRI L | 1 | 1 | LATIFA E | 10-016 | 11-026 | 11 -035 |  | 12-007 | 13-002F | 12-054F |  |  | 12-055 |  |  |  |  |  |  |  |  |  |  |  |  |  |  |
| 142241440a | Manufacturing of parts for the CV construction - Proc Part B | 302d | 2012-03-12 | 2013-05-24 | 9-120M FS+105d, 142241435a | 20d | 0d |  | PROCUREMENT>$50K 69 NO ESCALATION FY13; PROCUREMENT<$50K 60 NO ESCALATION FY13 | 90,000 | ELOUADRHIRI L | 1 | 1 | LATIFA E | 10-016 | 11-026 | 11 -035 |  | 12-007 | 13-002F | 12-054F |  |  | 12-055 |  |  |  |  |  |  |  |  |  |  |  |  |  |  |
| 142241575 | Manufacturing of the composite exit window - Proc | 268d | 2012-04-03 | 2013-04-30 | 142241570 FS+140d | 106d |  |  | PROCUREMENT<$50K 60 NO ESCALATION FY13 | 22,000 | ELOUADRHIRI L | 1 | 1 | LATIFA E | 10-016 | 11-026 | 11 -035 |  | 12-007 | 13-002F |  |  |  |  |  |  |  |  |  |  |  |  |  |  |  |  |  |  |
| 142241405b | Assembly of the mirror with rings - Lab FY12 | 105d | 2012-05-02 | 2012-09-28 | 142241300b, 142241405a FS+121d | 20d | 0d |  | SCIENTIST [128.78 h]; MECH DES [6.44 h]; MECH TECH [820.69 h]; VISTNG USERS [193.26 h]; MECH ENG [24.14 h] | 51,303.25 | ELOUADRHIRI L | 1 | 1 | LATIFA E | 10-016 | 11-026 | 11 -035 | 12-001 | 12-007 | 13-002F |  |  | 12-053 |  |  |  |  |  |  |  |  |  |  |  |  |  |  |  |
| 142241382a | Precision trimming of 12 identical sets of 5 substrates (60 substrates total) - Additional Expenses FY13 | 20d | 2012-10-01 | 2012-10-26 | 142241382 | 228d |  |  | MSHOP | 726.42 | ELOUADRHIRI L | 1 | 1 | LATIFA E | 10-016 | 11-026 | 11 -035 |  | 12-007 | 13-002F |  |  | 12-053 |  |  |  |  |  |  |  |  |  |  |  |  |  |  |  |
| 142241405ba | Assembly of the mirror with rings - Lab FY13 | 228d | 2012-10-01 | 2013-08-30 | 142241405b | 20d |  |  | SCIENTIST [279.62 h]; MECH DES [13.99 h]; MECH TECH [1782.07 h]; VISTNG USERS [419.64 h]; MECH ENG [52.41 h] | 114,959.05 | ELOUADRHIRI L | 1 | 1 | LATIFA E | 10-016 | 11-026 | 11 -035 | 12-001 | 12-007 | 13-002F |  |  | 12-053 |  | 13-014 |  |  |  |  |  |  |  |  |  |  |  |  |  |
| 142241445a | Manufacturing of Central Dish for the containment vessel FY13 | 164d | 2012-10-01 | 2013-05-31 | 142241445 | 49d | 0d |  | MSHOP | 29,864.42 | ELOUADRHIRI L | 1 | 1 | LATIFA E | 10-016 | 11-026 | 11 -035 |  | 12-007 | 13-002F | 12-054F |  | 12-053 |  |  |  |  |  |  |  |  |  |  |  |  |  |  |  |
| 142241472 | Procurement of PS for Compensation Coils | 164d | 2012-10-01 | 2013-05-31 | 9-130M | 84d |  |  | PROCUREMENT<$50K 60 | 6,191.4 | ELOUADRHIRI L | 1 | 1 | LATIFA E | 10-016 | 11-026 | 11 -035 |  | 12-007 | 13-002F |  |  |  |  |  |  |  |  |  |  |  |  |  |  |  |  |  |  |
| 142241647a | Proc of components for the HTCC Light Monitoring System | 104d | 2012-10-01 | 2013-03-07 | 142241647 FS+10d, 9-130M | 20d | 0d |  | PROCUREMENT<$50K 60 | 9,080.72 | ELOUADRHIRI L | 1 | 1 | LATIFA E | 10-016 | 11-026 | 11 -035 |  | 12-007 | 13-002F |  |  |  |  |  | 12-027 |  |  |  |  |  |  |  |  |  |  |  |  |
| 142241585 | Assembly of the photo tube housing unit (PMT, HV divider, Winston Cone, Magnetic Shield) - Lab | 63d | 2012-12-21 | 2013-03-29 | 142241525, 142241460 FS-171d, 142241515, 142241520, 142241500, 142241505, 142241210, 142241475a, 142241510, 142241490 | 52d | 32d |  | MECH TECH [80 h]; ELEC TECH [20 h]; VISTNG USERS [60 h] | 5,776.6 | ELOUADRHIRI L | 1 | 1 | LATIFA E | 10-016 | 11-026 | 11 -035 |  | 12-007 | 13-002F | 12-054 |  |  |  |  |  |  |  |  |  |  |  |  |  |  |  |  |  |
| 142241450b | Assembly of the CV - Lab Revised | 137d | 2013-01-17 | 2013-08-01 | 142241440 FS-90d, 142241445a FS-123d, 142241440a FS-90d, 142241450a | 20d | 0d |  | MECH TECH [1120 h]; VISTNG USERS [133.19 h]; SCIENTIST [560 h] | 94,821.94 | ELOUADRHIRI L | 1 | 1 | LATIFA E | 10-016 | 11-026 | 11 -035 | 12-001 | 12-007 | 13-002F | 12-054 |  |  |  |  |  |  |  |  |  |  |  |  |  |  |  |  |  |
| 142241647b | Assembly of optical components and reference detectors in the Aluminum box | 122d | 2013-03-12 | 2013-08-30 | 142241647a FS+2d | 20d | 0d |  | PD UNIV STUDNT [54.37 h]; PD UNIV STAFF [20.71 h] | 1,799.46 | ELOUADRHIRI L | 1 | 1 | LATIFA E | 10-016 | 11-026 | 11 -035 |  | 12-007 | 13-002F |  |  |  |  | 13-014 | 12-027 |  |  |  |  |  |  |  |  |  |  |  |  |
| 142241647c | Tests of optical components and reference detectors in the Aluminum box | 119d | 2013-03-15 | 2013-08-30 | 142241647b FS-119d | 20d |  |  | PD UNIV STUDNT [24.13 h]; PD UNIV STAFF [12.07 h] | 965.34 | ELOUADRHIRI L | 1 | 1 | LATIFA E | 10-016 | 11-026 | 11 -035 |  | 12-007 | 13-002F |  |  |  |  | 13-014 | 12-027 |  |  |  |  |  |  |  |  |  |  |  |  |
| 142241455 | Quality control fo the CV construction - Lab | 93d | 2013-04-22 | 2013-08-30 | 142241450b FS-72d | 52d | 0d |  | SCIENTIST [31.52 h]; MECH DES [31.52 h] | 3,864.02 | ELOUADRHIRI L | 1 | 1 | LATIFA E | 10-016 | 11-026 | 11 -035 |  | 12-007 | 13-002F | 12-054 |  |  |  | 13-014 |  |  |  |  |  |  |  |  |  |  |  |  |  |
| 142241590 | Installation of 48 housing units - Lab | 76d | 2013-05-15 | 2013-08-30 | 142241450b FS-55d, 142241585 | 20d | 0d |  | MECH TECH [76 h] | 3,485.36 | ELOUADRHIRI L | 1 | 1 | LATIFA E | 10-016 | 11-026 | 11 -035 |  | 12-007 | 13-002F | 12-054 |  |  |  | 13-014 |  |  |  |  |  |  |  |  |  |  |  |  |  |
| 142241595 | Quality control of the housing unit assembly and installation - Lab | 76d | 2013-05-15 | 2013-08-30 | 142241590 FS-76d, 142241585 | 20d |  |  | SCIENTIST [19 h] | 1,384.34 | ELOUADRHIRI L | 1 | 1 | LATIFA E | 10-016 | 11-026 | 11 -035 |  | 12-007 | 13-002F | 12-054 |  |  |  | 13-014 |  |  |  |  |  |  |  |  |  |  |  |  |  |
| 142241460 | Test of the CV on structural stability - Lab | 20d | 2013-08-05 | 2013-08-30 | 142241455 FS-20d | 52d | 0d |  | SCIENTIST [17.78 h]; MECH DES [17.78 h]; MECH ENG [17.78 h] | 3,465.21 | ELOUADRHIRI L | 1 | 1 | LATIFA E | 10-016 | 11-026 | 11 -035 |  | 12-007 | 13-002F | 12-054 |  |  |  | 13-014 |  |  |  |  |  |  |  |  |  |  |  |  |  |
| 142241580 | Procurement of miscellaneous parts - Proc | 1d | 2013-08-30 | 2013-08-30 | 9-130M FS+227d | 20d |  |  | PROCUREMENT<$50K 60 NO ESCALATION FY11 | 70.18 | ELOUADRHIRI L | 1 | 1 | LATIFA E | 10-016 | 11-026 | 11 -035 |  | 12-007 | 13-002F |  |  |  |  | 13-014 |  |  |  |  |  |  |  |  |  |  |  |  |  |
| 142241600 | Assembly of the composite carbon cone - Lab (Future Activity Complete prior to Rebaseline) | 1d | 2013-08-30 | 2013-08-30 | 9-130M FS+227d | 20d |  |  | MECH TECH |  | ELOUADRHIRI L | 1 | 1 | LATIFA E | 10-016 | 11-026 | 11 -035 |  | 12-007 | 13-002F | 12-054 |  |  |  | 13-014 |  |  |  |  |  |  |  |  |  |  |  |  |  |
| 142241655 | Re-Baseline Actuals Adjustment | 1d | 2013-08-30 | 2013-08-30 | 9-130M FS+227d | 20d |  |  | PROCUREMENT>$50K 69 NO ESCALATION | 452,568.48 | ELOUADRHIRI L | 1 | 1 | LATIFA E |  |  |  |  |  |  |  |  |  |  | 13-014 |  | ADJ |  |  |  |  |  |  |  |  |  |  |  |
| 242241370 | Assembly, tests and QA of additional substrates (up to 10 substrates total) FY13 | 20d | 2013-09-03 | 2013-09-30 | 9-130M FS+228d | 526.5d | 0d | 8/5 M-F w/JLAB Holidays ReBaseline | VISTNG USERS [5.71 h]; MECH TECH [5.71 h] | 376.1 | ELOUADRHIRI L | 1 | 1 | LATIFA E | 10-016 | 11-026 | 11 -035 | 12-001 | 12-007 | 13-002F |  |  |  |  |  |  |  | 242241370 | U | PE | 13-015 | PR |  |  |  |  |  |  |
| 242241372 | Precision trimming of additional substrates (up to 10 substrates total) - Labor/Expenses FY13 | 20d | 2013-09-03 | 2013-09-30 | 9-130M FS+228d | 494d | 0d | 8/5 M-F w/JLAB Holidays ReBaseline | VISTNG USERS [6.45 h]; SUPPLIES & MATERIALS | 935.13 | ELOUADRHIRI L | 1 | 1 | LATIFA E | 10-016 | 11-026 | 11 -035 | 12-001 | 12-007 | 13-002F |  |  |  |  |  |  |  | 242241372 | D | PE | 13-015 | PR | EJ |  |  |  |  |  |
| 242241390 | Coating of 60 substrates with Al + MgF2 - Proc | 72d | 2013-09-03 | 2013-12-13 | 9-130M FS+228d | 159d | 0d | 8/5 M-F w/JLAB Holidays ReBaseline | PROCUREMENT<$50K 60 NO ESCALATION FY14 | 13,250 | ELOUADRHIRI L | 1 | 1 | LATIFA E | 10-016 | 11-026 | 11 -035 |  | 12-007 | 13-002F | 12-054 |  |  |  |  |  |  | 242241390 | U |  | 13-015 | PR |  | y | OB | OB |  |  |
| 242241400 | UCONN Quality control of 60 coated substrates - Lab | 234d | 2013-09-03 | 2014-08-13 | 242241390 FS-72d | 159d | 0d | 8/5 M-F w/JLAB Holidays ReBaseline | PROCUREMENT<$50K 60 NO ESCALATION FY14 | 2,136 | ELOUADRHIRI L | 1 | 1 | LATIFA E | 10-016 | 11-026 | 11 -035 | 12-001 | 12-007 | 13-002F |  |  |  |  |  |  |  | 242241395 | U | PE | 13-015 | PR |  | y | OB | OB |  |  |
| 242241415 | Checks of geometry of mirror half-sectors - Expenses FY13 | 20d | 2013-09-03 | 2013-09-30 | 9-130M FS+228d | 168d | 0d | 8/5 M-F w/JLAB Holidays ReBaseline | SUPPLIES & MATERIALS | 49.26 | ELOUADRHIRI L | 1 | 1 | LATIFA E | 10-016 | 11-026 | 11 -035 | 12-001 | 12-007 | 13-002F |  |  |  |  |  |  |  | 242241415 | H |  | 13-015 | PR | EJ |  |  |  |  |  |
| 242241450aa | Manufacturing of top level assembly parts of the CV construction FY13 | 20d | 2013-09-03 | 2013-09-30 | 9-130M FS+228d | 273d | 0d | 8/5 M-F w/JLAB Holidays ReBaseline | SUPPLIES & MATERIALS | 5,555.56 | ELOUADRHIRI L | 1 | 1 | LATIFA E | 10-016 | 11-026 | 11 -035 | 12-001 | 12-007 | 13-002F | 12-054 |  |  |  |  |  |  | 242241450aa | D | PE | 13-015 | PR | PE |  |  |  |  |  |
| 242241450b | Assembly of the CV FY13 | 20d | 2013-09-03 | 2013-09-30 | 242241450aaa FS-70d, 9-130M FS+228d, 242241450aa FS-70d | 257d | 0d | 8/5 M-F w/JLAB Holidays ReBaseline | MECH TECH [118.46 h] | 5,432.58 | ELOUADRHIRI L | 1 | 1 | LATIFA E | 10-016 | 11-026 | 11 -035 | 12-001 | 12-007 | 13-002F | 12-054 |  |  |  |  |  |  | 242241450b | S | PE | 13-015 | PR |  |  |  |  | ST |  |
| 242241452 | Vend Fab HTCC Support Cart | 20d | 2013-09-03 | 2013-09-30 | 9-130M FS+228d | 551d | 548d | 8/5 M-F w/JLAB Holidays ReBaseline | PROCUREMENT<$50K 60 | 16,272.97 | ELOUADRHIRI L | 1 | 1 | LATIFA E | 10-016 | 11-026 | 11 -035 | 12-001 | 12-007 | 13-002F | 12-054 |  |  |  |  |  |  | 242241580 | D |  | 13-015 | PR | PE | y | PE | OB |  |  |
| 242241457 | HTCC Winston Cone Fabricate finals | 20d | 2013-09-03 | 2013-09-30 | 9-130M FS+228d | 551d | 548d | 8/5 M-F w/JLAB Holidays ReBaseline | PROCUREMENT>$50K 69; PROCUREMENT<$50K 60 | 3,300 | ELOUADRHIRI L | 1 | 1 | LATIFA E | 10-016 | 11-026 | 11 -035 | 12-001 | 12-007 | 13-002F | 12-054 |  |  |  |  |  |  | 242241580 | D |  | 13-015 | PR | PE | y | PE | OB |  |  |
| 242241462 | HTCC Consumables | 20d | 2013-09-03 | 2013-09-30 | 9-130M FS+228d | 551d | 548d | 8/5 M-F w/JLAB Holidays ReBaseline | PROCUREMENT<$50K 60 | 304.92 | ELOUADRHIRI L | 1 | 1 | LATIFA E | 10-016 | 11-026 | 11 -035 | 12-001 | 12-007 | 13-002F | 12-054 |  |  |  |  |  |  | 242241580 | D |  | 13-015 | PR | PE | y | PE | OB |  |  |
| 242241580 | Procurement of miscellaneous parts - Proc | 107d | 2013-09-03 | 2014-02-13 | 9-130M FS+228d | 157d | 0d | 8/5 M-F w/JLAB Holidays ReBaseline | SUPPLIES & MATERIALS; PROCUREMENT<$50K 60 NO ESCALATION FY14 | 5,775 | ELOUADRHIRI L | 1 | 1 | LATIFA E | 10-016 | 11-026 | 11 -035 | 12-001 | 12-007 | 13-002F | 12-054 |  |  |  |  |  |  | 242241580 | D |  | 13-015 | PR | PE |  | PE |  |  |  |
| 242241580a | Procurement of miscellaneous parts - Expenses FY13 | 20d | 2013-09-03 | 2013-09-30 | 9-130M FS+228d | 157d | 0d | 8/5 M-F w/JLAB Holidays ReBaseline | SUPPLIES & MATERIALS | 1,308.41 | ELOUADRHIRI L | 1 | 1 | LATIFA E | 10-016 | 11-026 | 11 -035 | 12-001 | 12-007 | 13-002F | 12-054 |  |  |  |  |  |  | 242241580 | D |  | 13-015 | PR | PE |  | PE |  |  |  |
| 242241455 | Quality control fo the CV construction - Lab FY13 | 10d | 2013-09-17 | 2013-09-30 | 242241450b FS-120d, 242241450ba FS-120d | 257d | 0d | 8/5 M-F w/JLAB Holidays ReBaseline | MECH TECH [11.51 h]; SCIENTIST [5.76 h] | 947.43 | ELOUADRHIRI L | 1 | 1 | LATIFA E | 10-016 | 11-026 | 11 -035 |  | 12-007 | 13-002F | 12-054 |  |  |  |  |  |  | 242241455 | S | PE | 13-015 | PR |  |  |  |  |  |  |
| 242241370a | Assembly, tests and QA of additional substrates (up to 10 substrates total) FY14 | 9.5d | 2013-10-01 | 2013-10-14 | 242241370, 9-130M FS+228d | 526.5d | 369.5d | 8/5 M-F w/JLAB Holidays ReBaseline | VISTNG USERS [6.29 h]; MECH TECH [6.29 h] | 426.82 | ELOUADRHIRI L | 1 | 1 | LATIFA E | 10-016 | 11-026 | 11 -035 | 12-001 | 12-007 | 13-002F |  |  |  |  |  |  |  | 242241370 | U | PE | 13-015 | PR |  |  |  |  |  | 14-001 |
| 242241372a | Precision trimming of additional substrates (up to 10 substrates total) - Labor/Expenses FY14 | 42d | 2013-10-01 | 2013-11-27 | 242241372, 9-130M FS+228d | 494d | 337d | 8/5 M-F w/JLAB Holidays ReBaseline | VISTNG USERS [13.55 h]; SUPPLIES & MATERIALS | 2,026.56 | ELOUADRHIRI L | 1 | 1 | LATIFA E | 10-016 | 11-026 | 11 -035 | 12-001 | 12-007 | 13-002F |  |  |  |  |  |  |  | 242241372 | D | PE | 13-015 | PR | EJ |  |  |  |  | 14-001 |
| 242241415a | Checks of geometry of mirror half-sectors - Expenses FY14 | 183d | 2013-10-01 | 2014-06-30 | 9-130M FS+228d, 242241415 | 168d | 0d | 8/5 M-F w/JLAB Holidays ReBaseline | SUPPLIES & MATERIALS | 465.12 | ELOUADRHIRI L | 1 | 1 | LATIFA E | 10-016 | 11-026 | 11 -035 | 12-001 | 12-007 | 13-002F |  |  |  |  |  |  |  | 242241415 | H |  | 13-015 | PR | EJ |  |  |  |  | 14-001 |
| 242241450aaa | Manufacturing of top level assembly parts of the CV construction FY14 | 34d | 2013-10-01 | 2013-11-15 | 9-130M FS+228d, 242241450aa | 273d | 16d | 8/5 M-F w/JLAB Holidays ReBaseline | SUPPLIES & MATERIALS | 9,745.72 | ELOUADRHIRI L | 1 | 1 | LATIFA E | 10-016 | 11-026 | 11 -035 | 12-001 | 12-007 | 13-002F | 12-054 |  |  |  |  |  |  | 242241450aa | D | PE | 13-015 | PR | PE |  |  |  |  | 14-001 |
| 242241450ba | Assembly of the CV FY14 | 110d | 2013-10-01 | 2014-03-18 | 242241450aaa FS-70d, 9-130M FS+228d, 242241450aa FS-70d, 242241450b | 257d | 0d | 8/5 M-F w/JLAB Holidays ReBaseline | MECH TECH [651.54 h] | 30,830.87 | ELOUADRHIRI L | 1 | 1 | LATIFA E | 10-016 | 11-026 | 11 -035 | 12-001 | 12-007 | 13-002F | 12-054 |  |  |  |  |  |  | 242241450b | S | PE | 13-015 | PR |  |  |  |  | ST | 14-001 |
| 242241455a | Quality control fo the CV construction - Lab FY14 | 129d | 2013-10-01 | 2014-04-14 | 242241450ba FS-120d, 242241455, 242241450b FS-120d | 257d | 0d | 8/5 M-F w/JLAB Holidays ReBaseline | MECH TECH [148.49 h]; SCIENTIST [74.24 h] | 12,608 | ELOUADRHIRI L | 1 | 1 | LATIFA E | 10-016 | 11-026 | 11 -035 |  | 12-007 | 13-002F | 12-054 |  |  |  |  |  |  | 242241455 | S | PE | 13-015 | PR |  |  |  |  |  | 14-001 |
| 242241580b | Procurement of miscellaneous parts - Expenses FY14 | 87d | 2013-10-01 | 2014-02-13 | 242241580a, 9-130M FS+228d | 157d | 0d | 8/5 M-F w/JLAB Holidays ReBaseline | SUPPLIES & MATERIALS | 5,873.15 | ELOUADRHIRI L | 1 | 1 | LATIFA E | 10-016 | 11-026 | 11 -035 | 12-001 | 12-007 | 13-002F | 12-054 |  |  |  |  |  |  | 242241580 | D |  | 13-015 | PR | PE |  | PE |  |  | 14-001 |
| 242241395 | Quality control of 60 coated substrates - Proc | 128d | 2013-10-03 | 2014-04-15 | 242241390 FS-50d | 243d | 84d | 8/5 M-F w/JLAB Holidays ReBaseline | PROCUREMENT<$50K 60 | 9,036.97 | ELOUADRHIRI L | 1 | 1 | LATIFA E | 10-016 | 11-026 | 11 -035 | 12-001 | 12-007 | 13-002F |  |  |  |  |  |  |  | 242241395 | U | PE | 13-015 | PR |  |  | OB |  |  | 14-001 |
| 242241395a | Quality control of 60 coated substrates - Lab | 212d | 2013-10-03 | 2014-08-13 | 242241390 FS-50d | 159d | 0d | 8/5 M-F w/JLAB Holidays ReBaseline | PD UNIV STUDNT [110.16 h]; MECH TECH [27.54 h]; PD UNIV STAFF [59.84 h]; SCIENTIST [45.22 h] | 9,534.48 | ELOUADRHIRI L | 1 | 1 | LATIFA E | 10-016 | 11-026 | 11 -035 | 12-001 | 12-007 | 13-002F |  |  |  |  |  |  |  | 242241395a | U | PE | 13-015 | PR |  |  |  |  |  | 14-001 |

Notes:
- 242241450b: Steps: Completion of the assembly major structural members of the CV; Attachment of the outer shells of the CV; Powerwash and painting of the CV; Placement of the cleaned/painted CV inside of the clean room
- 242241450ba: Steps: Completion of the assembly major structural members of the CV; Attachment of the outer shells of the CV; Powerwash and painting of the CV; Placement of the cleaned/painted CV inside of the clean room

| ID | WBS | Activity | Type | Duration | Start | Finish | Predecessors | Total float | Free float | Calendar | Resources | Cost | Original Activity ID Rebaseline | RESP - Responsibility | STRT%COMP for CM EVM | FNSH%COMP for CM EVM | EVMS Reporting Codes | CAM RESPONSIBLE | CR 10-016 | CR 11-026 | CR 11-035 | CR 12-007 | CR 13-002 | BOE Expenses | CR 13-015 | Post Rebaseline | CR 14-001 | CR 12-001 | BOE Labor | CR 12-027 | BOE Procurement | Activities with Steps | CR 12-053 | CR 12-054 | PHAS - Project Phase | Advance Purchase Plan > 500K | CR 08-016 | CR 09-012 | CR 09-030 Repair | CR 13-014 |
| --- | --- | --- | --- | --- | --- | --- | --- | --- | --- | --- | --- | --- | --- | --- | --- | --- | --- | --- | --- | --- | --- | --- | --- | --- | --- | --- | --- | --- | --- | --- | --- | --- | --- | --- | --- | --- | --- | --- | --- | --- |
| 242241300 |  | Tooling manufacturing for Quality Control of combined mirror assembly |  | 85d | 2013-11-01 | 2014-03-14 | 9-140M FS+23d | 265d | 106d | 8/5 M-F w/JLAB Holidays ReBaseline | MSHOP | 25,797.5 | 242241300 | ELOUADRHIRI L | 1 | 1 | U | LATIFA E | 10-016 | 11-026 | 11 -035 | 12-007 | 13-002F | EJ | 13-015 | PR | 14-001 |  |  |  |  |  |  |  |  |  |  |  |  |  |
| 242241405 |  | Dry Fit of Preformed Mirror facets into rings - Lab |  | 157d | 2013-11-01 | 2014-06-25 | 9-140M FS+23d | 159d | 0d | 8/5 M-F w/JLAB Holidays ReBaseline | SCIENTIST [160 h]; MECH DES [40 h]; MECH TECH [480 h]; VISTNG USERS [560 h] | 48,324.8 | 242241405 | ELOUADRHIRI L | 1 | 1 | S | LATIFA E | 10-016 | 11-026 | 11 -035 | 12-007 | 13-002F |  | 13-015 | PR | 14-001 | 12-001 | PE |  |  |  |  |  |  |  |  |  |  |  |
| 242241647a |  | Proc of components for the HTCC Light Monitoring System |  | 172d | 2013-11-01 | 2014-07-17 | 9-140M FS+23d | 274d | 117d | 8/5 M-F w/JLAB Holidays ReBaseline | PROCUREMENT<$50K 60 | 2,966.71 | 242241647a | ELOUADRHIRI L | 1 | 1 | D | LATIFA E | 10-016 | 11-026 | 11 -035 | 12-007 | 13-002F |  | 13-015 | PR | 14-001 |  |  | 12-027 | EV |  |  |  |  |  |  |  |  |  |
| 242241405b |  | Assembly of the mirror with rings - Lab |  | 150d | 2014-02-05 | 2014-09-05 | 242241405 FS-100d | 159d | 0d | 8/5 M-F w/JLAB Holidays ReBaseline | MECH DES [60 h]; MECH TECH [2340 h]; MECH ENG [60 h] | 118,287 | 242241405b | ELOUADRHIRI L | 1 | 1 | S | LATIFA E | 10-016 | 11-026 | 11 -035 | 12-007 | 13-002F |  | 13-015 | PR | 14-001 | 12-001 | PE |  |  | ST | 12-053 |  |  |  |  |  |  |  |
| 242241410 |  | Quality control of assembled mirror half-sectors - Lab |  | 150d | 2014-02-05 | 2014-09-05 | 242241405 FS-100d | 159d | 0d | 8/5 M-F w/JLAB Holidays ReBaseline | PD UNIV STAFF [80 h]; MECH ENG [80 h]; PD UNIV STUDNT [1280 h]; SCIENTIST [640 h] | 73,416 | 242241410 | ELOUADRHIRI L | 1 | 1 | S | LATIFA E | 10-016 | 11-026 | 11 -035 | 12-007 | 13-002F |  | 13-015 | PR | 14-001 | 12-001 | PE |  |  | ST |  |  |  |  |  |  |  |  |
| 242241430 |  | Procurement of HEPA filters for the HTCC Clean Room |  | 290d | 2014-02-05 | 2015-04-06 | 9-140M FS+80d | 166d | 9d | 8/5 M-F w/JLAB Holidays ReBaseline | PROCUREMENT<$50K 60 NO ESCALATION FY15 | 5,572.26 | 242241430 | ELOUADRHIRI L | 1 | 1 | U | LATIFA E | 10-016 | 11-026 | 11 -035 | 12-007 | 13-002F |  | 13-015 | PR | 14-001 |  |  |  | PE |  |  |  |  |  |  |  |  |  |
| 242241435 |  | Change Out of HEPA filters for the HTCC Clean Room |  | 291d | 2014-02-05 | 2015-04-07 | 9-140M FS+80d | 165d | 8d | 8/5 M-F w/JLAB Holidays ReBaseline | MECH TECH [48 h] | 2,271.36 | 242241435 | ELOUADRHIRI L | 1 | 1 | U | LATIFA E | 10-016 | 11-026 | 11 -035 | 12-007 | 13-002F |  | 13-015 | PR | 14-001 |  | PE |  |  |  |  |  |  |  |  |  |  |  |
| 242241585 |  | Assembly of the photo tube housing unit (PMT, HV divider, Winston Cone, Magnetic Shield) - Lab |  | 163d | 2014-02-14 | 2014-10-03 | 242241580a, 242241580, 242241455 FS-260d, 242241455a FS-260d, 242241580b | 157d | 0d | 8/5 M-F w/JLAB Holidays ReBaseline | SCIENTIST [10 h]; MECH TECH [80 h]; ELEC TECH [20 h]; VISTNG USERS [240 h] | 10,418.8 | 242241585 | ELOUADRHIRI L | 1 | 1 | S | LATIFA E | 10-016 | 11-026 | 11 -035 | 12-007 | 13-002F |  | 13-015 | PR | 14-001 |  | PE |  |  |  |  | 12-054 |  |  |  |  |  |  |
| 242241600 |  | Assembly of the composite carbon cone - Lab |  | 20d | 2014-02-17 | 2014-03-14 | 242241455a FS-41d, 242241455 FS-41d | 301d | 0d | 8/5 M-F w/JLAB Holidays ReBaseline | MECH TECH [80 h] | 3,785.6 | 242241600 | ELOUADRHIRI L | 1 | 1 | H | LATIFA E | 10-016 | 11-026 | 11 -035 | 12-007 | 13-002F |  | 13-015 | PR | 14-001 |  | PE |  |  |  |  | 12-054 |  |  |  |  |  |  |
| 242241528 |  | Assembly of the HTCC Gas System |  | 65d | 2014-03-04 | 2014-06-03 | 9-140M FS+99d | 372d | 215d | 8/5 M-F w/JLAB Holidays ReBaseline | ELEC TECH [80 h]; VISTNG USERS [120 h]; SCIENTIST [20 h]; MECH TECH [80 h] | 11,519.2 | 242241528 | ELOUADRHIRI L | 1 | 1 | S | LATIFA E | 10-016 | 11-026 | 11 -035 | 12-007 | 13-002F |  | 13-015 | PR | 14-001 |  | PE |  |  |  |  |  |  |  |  |  |  |  |
| 242241605 |  | Installation of the assembled carbon cone - Lab |  | 107d | 2014-04-14 | 2014-09-12 | 242241600 FS+20d | 301d | 144d | 8/5 M-F w/JLAB Holidays ReBaseline | MECH ENG [20 h]; SCIENTIST [20 h]; MECH TECH [80 h] | 6,782.6 | 242241605 | ELOUADRHIRI L | 1 | 1 | S | LATIFA E | 10-016 | 11-026 | 11 -035 | 12-007 | 13-002F |  | 13-015 | PR | 14-001 |  | PE |  |  | ST |  | 12-054 |  |  |  |  |  |  |
| 242241610 |  | Installation of the composite exit window - Lab |  | 107d | 2014-04-14 | 2014-09-12 | 242241455 FS-1d, 242241455a FS-1d | 301d | 144d | 8/5 M-F w/JLAB Holidays ReBaseline | MECH TECH [80 h] | 3,785.6 | 242241610 | ELOUADRHIRI L | 1 | 1 | S | LATIFA E | 10-016 | 11-026 | 11 -035 | 12-007 | 13-002F |  | 13-015 | PR | 14-001 |  | PE |  |  | ST |  | 12-054 |  |  |  |  |  |  |
| 242241417 |  | Manufacturing of modified HV-dividers for the 5" PMTs (50 units)-Lab |  | 62d | 2014-05-05 | 2014-07-31 | 242241415a FS-40d, 242241415 FS-40d | 168d | 9d | 8/5 M-F w/JLAB Holidays ReBaseline | ELEC TECH [40 h] | 1,879.6 | 242241417 | ELOUADRHIRI L | 1 | 1 | H | LATIFA E | 10-016 | 11-026 | 11 -035 | 12-007 | 13-002F |  | 13-015 | PR | 14-001 | 12-001 | PE |  |  |  |  |  |  |  |  |  |  |  |
| 242241630 |  | Installation of a temporary CO2 gas supply system - Lab |  | 44d | 2014-06-17 | 2014-08-18 | 9-140M FS+173d | 319d | 162d | 8/5 M-F w/JLAB Holidays ReBaseline | MECH TECH [140 h] | 6,624.8 | 242241630 | ELOUADRHIRI L | 1 | 1 | H | LATIFA E | 10-016 | 11-026 | 11 -035 | 12-007 | 13-002F |  | 13-015 | PR | 14-001 |  | PE |  |  |  |  | 12-054 |  |  |  |  |  |  |
| 242241425 |  | Quality control of the final mirror assembly - Lab |  | 44d | 2014-08-14 | 2014-10-15 | 242241395a, 242241400, 242241405b FS-16d, 242241410 FS-16d, 242241417, 242241300, 242241395 | 159d | 0d | 8/5 M-F w/JLAB Holidays ReBaseline | PD UNIV STAFF [352 h]; SCIENTIST [352 h]; MECH TECH [352 h] | 64,180.16 | 242241425 | ELOUADRHIRI L | 1 | 1 | S | LATIFA E | 10-016 | 11-026 | 11 -035 | 12-007 | 13-002F | EJ | 13-015 | PR | 14-001 |  | PE |  |  |  |  |  |  |  |  |  |  |  |
| 242241590 |  | Installation of 48 housing units - Lab |  | 43d | 2014-10-06 | 2014-12-05 | 242241450b FS-55d, 242241455 FS+21d, 242241585, 242241450ba FS-55d, 242241455a FS+21d | 157d | 0d | 8/5 M-F w/JLAB Holidays ReBaseline | SCIENTIST [20 h]; VISTNG USERS [240 h]; MECH TECH [160 h] | 14,016.4 | 242241590 | ELOUADRHIRI L | 1 | 1 | S | LATIFA E | 10-016 | 11-026 | 11 -035 | 12-007 | 13-002F |  | 13-015 | PR | 14-001 |  | PE |  |  |  |  | 12-054 |  |  |  |  |  |  |
| 242241595 |  | Quality control of the housing unit assembly and installation - Lab |  | 43d | 2014-10-06 | 2014-12-05 | 242241590 FS-43d, 242241585 | 157d | 0d | 8/5 M-F w/JLAB Holidays ReBaseline | VISTNG USERS [40 h]; SCIENTIST [80 h] | 6,838 | 242241595 | ELOUADRHIRI L | 1 | 1 | H | LATIFA E | 10-016 | 11-026 | 11 -035 | 12-007 | 13-002F |  | 13-015 | PR | 14-001 |  | PE |  |  |  |  | 12-054 |  |  |  |  |  |  |
| 242241647d5 |  | Quality control of the installed items |  | 106d | 2014-11-06 | 2015-04-17 | 242241647d FS-62d | 157d | 0d | 8/5 M-F w/JLAB Holidays ReBaseline | SCIENTIST [280 h]; VISTNG USERS [280 h]; PD UNIV STUDNT [222.4 h]; PD UNIV STAFF [97.6 h] | 35,181.47 | 242241647d5 | ELOUADRHIRI L | 1 | 1 | S | LATIFA E | 10-016 | 11-026 | 11 -035 | 12-007 | 13-002F |  | 13-015 | PR | 14-001 |  | PE | 12-027 |  | ST |  |  |  |  |  |  |  |  |
| 242241647d |  | Installation of LMS |  | 44d | 2014-12-04 | 2015-02-16 | 242241595 FS-2d, 242241647a FS-21d | 157d | 0d | 8/5 M-F w/JLAB Holidays ReBaseline | SCIENTIST [4 h]; VISTNG USERS [80 h]; PD UNIV STUDNT [53.33 h]; PD UNIV STAFF [53.2 h] | 5,736.75 | 242241647d | ELOUADRHIRI L | 1 | 1 | S | LATIFA E | 10-016 | 11-026 | 11 -035 | 12-007 | 13-002F |  | 13-015 | PR | 14-001 |  | PE | 12-027 |  |  |  |  |  |  |  |  |  |  |
| 242241640 |  | Installation ofthe ellipsoidal mirror - Lab |  | 40d | 2015-01-20 | 2015-03-16 | 242241425 FS+57d | 159d | 0d | 8/5 M-F w/JLAB Holidays ReBaseline | VISTNG USERS [109.47 h]; SCIENTIST [72.98 h]; MECH DES [18.25 h]; MECH TECH [821.05 h]; MECH ENG [18.25 h] | 48,891.49 | 242241640 | ELOUADRHIRI L | 1 | 1 | S | LATIFA E | 10-016 | 11-026 | 11 -035 | 12-007 | 13-002F |  | 13-015 | PR | 14-001 |  | PE |  |  | ST |  | 12-054 |  |  |  |  |  |  |
| 242241645 |  | Optical tests of mirror geometry in situ - Lab |  | 21d | 2015-03-18 | 2015-04-15 | 242241640 FS+1d | 159d | 2d | 8/5 M-F w/JLAB Holidays ReBaseline | VISTNG USERS [80 h]; PD UNIV STAFF [40 h]; PD UNIV STUDNT [40 h]; SCIENTIST [80 h] | 10,509.2 | 242241645 | ELOUADRHIRI L | 1 | 1 | H | LATIFA E | 10-016 | 11-026 | 11 -035 | 12-007 | 13-002F |  | 13-015 | PR | 14-001 |  | PE |  |  |  |  | 12-054 |  |  |  |  |  |  |
| 242241650M |  | HTCC Ready for Installation in the Hall | milestone | 0d | 2015-04-17 | 2015-04-17 | 242241645, 242241605, 242241595, 242241372a, 242241430, 242241647d5, 242241435, 242241590, 242241370a, 242241370, 242241372, 242241528, 242241610, 242241630 | 157d | 0d | 8/5 M-F w/JLAB Holidays ReBaseline |  |  | 242241650M | ELOUADRHIRI L | 1 | 1 | M | LATIFA E | 10-016 | 11-026 | 11 -035 | 12-007 | 13-002F |  | 13-015 | PR |  |  |  | 12-027 |  |  |  |  |  |  |  |  |  |  |
|  | 2 | **1.4.2.2.4.2 LOW THRESHOLD CC** |  |  | 2011-11-01 | 2015-02-10 |  |  |  |  |  |  |  |  |  |  |  |  |  |  |  |  |  |  |  |  |  |  |  |  |  |  |  |  |  |  |  |  |  |  |
| 142242120 |  | Build Scale Model of Box |  | 80d | 2011-11-01 | 2012-03-05 | 9-120M FS+21d | 126d | 0d |  | MECH TECH [80 h]; MECH DES [40 h] | 5,482 |  | ELOUADRHIRI L | 1 | 1 |  | LATIFA E |  |  |  | 12-007 | 13-002F |  |  |  |  |  |  |  |  |  |  |  | IN | APP |  |  |  |  |
| 142242000M |  | Space Ready | milestone | 0d | 2012-01-12 | 2012-01-12 | 9-120M FS+65d | 330d | 0d |  |  |  |  | ELOUADRHIRI L | 1 | 1 |  | LATIFA E |  |  |  | 12-007 | 13-002F |  |  |  |  |  |  |  |  |  |  |  |  | APP |  |  |  |  |
| 142242005 |  | Procure Shelving/Desk/Oscilliscope and Computers for LTCC |  | 36d | 2012-01-12 | 2012-03-05 | 12222080, 142242000M | 380d | 0d |  | PROCUREMENT>$50K 69; SCIENTIST [20 h] | 23,912.2 |  | ELOUADRHIRI L | 1 | 1 |  | LATIFA E |  | 11-026 | 11 -035 | 12-007 | 13-002F |  |  |  |  |  |  |  |  |  |  |  |  | APP |  |  |  |  |
| 142242015 |  | Transport PMTs to new space |  | 22d | 2012-01-12 | 2012-02-13 | 142242000M | 330d | 0d |  | MECH TECH [20 h] | 888.8 |  | ELOUADRHIRI L | 1 | 1 |  | LATIFA E |  |  |  | 12-007 | 13-002F |  |  |  |  |  |  |  |  |  |  |  | IN | APP |  |  |  |  |
| 142242035 |  | Final Manufacturing Drawings of Alignment Tool |  | 63d | 2012-01-18 | 2012-04-16 | 9-120M FS+68d | 99d | 0d |  | VISTNG USERS [36 h]; SCIENTIST [36 h]; MECH DES [48 h] | 5,550 |  | ELOUADRHIRI L | 1 | 1 |  | LATIFA E |  |  |  | 12-007 | 13-002F |  |  |  |  |  |  |  |  |  |  |  | IN | APP |  |  |  |  |
| 142242130 |  | Gas Window Simulation |  | 85d | 2012-01-20 | 2012-05-18 | 9-120M FS+70d, 142242120 FS-31d | 236d | 0d |  | SCIENTIST [40 h]; VISTNG USERS [40 h] | 3,597.6 |  | ELOUADRHIRI L | 1 | 1 |  | LATIFA E |  |  |  | 12-007 | 13-002F |  |  |  |  |  |  |  |  |  |  |  | IN | APP |  |  |  |  |
| 142242140 |  | Box Walls Simulation |  | 85d | 2012-01-20 | 2012-05-18 | 9-120M FS+70d, 142242120 FS-31d | 126d | 0d |  |  |  |  | ELOUADRHIRI L | 1 | 1 |  | LATIFA E |  |  |  | 12-007 | 13-002F |  |  |  |  |  |  |  |  |  |  |  | IN | APP |  |  |  |  |
| 142242020 |  | Transport HV Electronics from Hall B to new space |  | 22d | 2012-02-06 | 2012-03-07 | 142242015 FS-6d | 330d | 0d |  | MECH TECH [20 h] | 888.8 |  | ELOUADRHIRI L | 1 | 1 |  | LATIFA E |  |  |  | 12-007 | 13-002F |  |  |  |  |  |  |  |  |  |  |  | IN | APP |  |  |  |  |
| 142242010 |  | Prepare electronics for new space |  | 14d | 2012-03-06 | 2012-03-23 | 142242005, 142242000M | 380d |  |  | VISTNG USERS [20 h]; SCIENTIST [20 h] | 1,798.8 |  | ELOUADRHIRI L | 1 | 1 |  | LATIFA E |  | 11-026 | 11 -035 | 12-007 | 13-002F |  |  |  |  |  |  |  |  |  |  |  | IN | APP | 08-016 | 09-012 | 09-030 |  |
| 142242025 |  | Installation of Electronics, Black Box for PMTS Quality Control |  | 25d | 2012-03-08 | 2012-04-11 | 142242020 | 330d | 0d |  | SCIENTIST [20 h]; VISTNG USERS [20 h] | 1,798.8 |  | ELOUADRHIRI L | 1 | 1 |  | LATIFA E |  |  |  | 12-007 | 13-002F |  |  |  |  |  |  |  |  |  |  |  | IN | APP |  |  |  |  |
| 142242125 |  | Gas Window Test on Scale Model |  | 45d | 2012-03-12 | 2012-05-11 | 142242120 FS+4d | 345d |  |  | MECH TECH [40 h]; MECH DES [20 h]; SCIENTIST [10 h]; VISTNG USERS [10 h] | 3,640.4 |  | ELOUADRHIRI L | 1 | 1 |  | LATIFA E |  |  |  | 12-007 | 13-002F |  |  |  |  |  |  |  |  |  |  |  | IN | APP |  |  |  |  |
| 142242030 |  | Quality Control of PMTs |  | 37d | 2012-04-12 | 2012-06-05 | 142242025, 142242015, 142242020 | 330d |  |  | SCIENTIST [40 h]; VISTNG USERS [80 h] | 4,370.8 |  | ELOUADRHIRI L | 1 | 1 |  | LATIFA E |  |  |  | 12-007 | 13-002F |  |  |  |  |  |  |  |  |  |  |  | IN | APP |  |  |  |  |
| 142242040 |  | Procurement Prep of Lasers |  | 21d | 2012-05-07 | 2012-06-06 | 142242035 FS+14d | 99d | 0d |  | SCIENTIST [20 h] | 1,412.2 |  | ELOUADRHIRI L | 1 | 1 |  | LATIFA E |  |  |  | 12-007 | 13-002F |  |  |  |  |  |  |  |  |  |  |  | IN | APP |  |  |  |  |
| 142242065M |  | Space Ready For LTCC Refurb | milestone | 0d | 2012-06-01 | 2012-06-01 | 9-120M FS+163d | 54d | 0d |  |  |  |  | ELOUADRHIRI L | 1 | 1 |  | LATIFA E |  |  |  | 12-007 | 13-002F |  |  |  |  |  |  |  |  |  |  | 12-054F |  | APP |  |  |  |  |
| 142242070 |  | Transport 6 CC Sectors to Work Space |  | 22d | 2012-06-01 | 2012-07-03 | 142242065M | 54d | 0d |  |  |  |  | ELOUADRHIRI L | 1 | 1 |  | LATIFA E |  |  |  | 12-007 | 13-002F |  |  |  |  |  |  |  |  |  |  | 12-054F | IN | APP |  |  |  |  |
| 142242145 |  | Complete Design Box Walls FY12 |  | 79d | 2012-06-11 | 2012-09-28 | 142242140 FS+13d | 126d | 0d |  | SCIENTIST [25.09 h]; VISTNG USERS [25.09 h]; MECH DES [98.52 h] | 7,002.3 |  | ELOUADRHIRI L | 1 | 1 |  | LATIFA E |  |  |  | 12-007 | 13-002F |  |  |  |  |  |  |  |  |  | 12-053 |  | IN | APP |  |  |  |  |
| 142242165 |  | Procure Cables FY12 |  | 79d | 2012-06-11 | 2012-09-28 | 9-120M FS+168d | 190d | 0d |  | SCIENTIST [23.07 h]; VISTNG USERS [23.07 h] | 2,074.91 |  | ELOUADRHIRI L | 1 | 1 |  | LATIFA E |  |  |  | 12-007 | 13-002F |  |  |  |  |  |  |  |  |  | 12-053 |  | IN | APP |  |  |  |  |
| 142242165b |  | Procure Cables Procurement |  | 137d | 2012-06-11 | 2012-12-21 | 9-120M FS+168d | 190d |  |  | PROCUREMENT<$50K 60 NO ESCALATION FY13 | 15,000 |  | ELOUADRHIRI L | 1 | 1 |  | LATIFA E |  |  |  | 12-007 | 13-002F |  |  |  |  |  |  |  |  |  | 12-053 |  | IN | APP |  |  |  |  |
| 142242220 |  | Online Calibration Design FY12 |  | 79d | 2012-06-11 | 2012-09-28 | 9-120M FS+168d | 20d | 0d |  | SCIENTIST [103.01 h]; VISTNG USERS [82.49 h] | 8,868.07 |  | ELOUADRHIRI L | 1 | 1 |  | LATIFA E |  |  |  | 12-007 | 13-002F |  |  |  |  |  |  |  |  |  | 12-053 |  | IN | APP |  |  |  |  |
| 142242135 |  | Gas Window Design FY12 |  | 74d | 2012-06-18 | 2012-09-28 | 142242130 FS+18d | 236d | 0d |  | MECH DES [34.42 h]; SCIENTIST [17.21 h]; VISTNG USERS [17.21 h] | 3,205.88 |  | ELOUADRHIRI L | 1 | 1 |  | LATIFA E |  |  |  | 12-007 | 13-002F |  |  |  |  |  |  |  |  |  | 12-053 |  | IN | APP |  |  |  |  |
| 142242050 |  | Alignment Tool Manufacturing |  | 69d | 2012-06-25 | 2012-09-28 | 142242040 FS+12d, 142242035 FS+47d | 99d | 79d |  | MSHOP; MECH DES [20 h]; VISTNG USERS [20 h] | 5,850 |  | ELOUADRHIRI L | 1 | 1 |  | LATIFA E |  |  |  | 12-007 | 13-002F |  |  |  |  |  |  |  |  |  |  |  | IN | APP |  |  |  |  |
| 142242075 |  | Transport Aligment Frame Support to Work Space |  | 23d | 2012-07-09 | 2012-08-08 | 142242070 FS+3d | 178d | 0d |  |  |  |  | ELOUADRHIRI L | 1 | 1 |  | LATIFA E |  |  |  | 12-007 | 13-002F |  |  |  |  |  |  |  |  |  |  |  | IN | APP |  |  |  |  |
| 142242085 |  | Quality Control of Elliptical/Hyperbolic mirrors |  | 22d | 2012-07-09 | 2012-08-07 | 142242070 FS+3d | 99d | 0d |  | SCIENTIST [80 h]; VISTNG USERS [80 h] | 7,195.2 |  | ELOUADRHIRI L | 1 | 1 |  | LATIFA E |  |  |  | 12-007 | 13-002F |  |  |  |  |  |  |  |  |  |  | 12-054F | IN | APP |  |  |  |  |
| 142242090 |  | Dimensions check of Elliptical/Hyperbolic mirrors |  | 25d | 2012-08-01 | 2012-09-05 | 142242085 FS-5d, 142242070 FS+20d | 99d | 70d |  | SCIENTIST [80 h]; VISTNG USERS [80 h] | 7,195.2 |  | ELOUADRHIRI L | 1 | 1 |  | LATIFA E |  |  |  | 12-007 | 13-002F |  |  |  |  |  |  |  |  |  |  | 12-054F | IN | APP |  |  |  |  |
| 142242080 |  | Installation and Aligment of Lasers, Tools and Frame Support |  | 22d | 2012-08-13 | 2012-09-12 | 142242075 FS+2d | 178d | 158d |  | MECH TECH [40 h]; SCIENTIST [20 h]; VISTNG USERS [20 h] | 3,576.4 |  | ELOUADRHIRI L | 1 | 1 |  | LATIFA E |  |  |  | 12-007 | 13-002F |  |  |  |  |  |  |  |  |  |  |  | IN | APP |  |  |  |  |
| 142242180 |  | Gas Line Design FY12 |  | 19d | 2012-09-04 | 2012-09-28 | 142242070 FS+43d | 54d | 0d |  | MECH DES [35.35 h]; SCIENTIST [8.84 h]; VISTNG USERS [8.84 h] | 2,497.88 |  | ELOUADRHIRI L | 1 | 1 |  | LATIFA E |  |  |  | 12-007 | 13-002F |  |  |  |  |  |  |  |  |  | 12-053 |  | IN | APP |  |  |  |  |
| 142242045 |  | Procurement Lasers |  | 79d | 2012-10-01 | 2013-01-30 | 142242040 FS+2d, 9-130M | 20d | 0d |  | SCIENTIST [20 h]; PROCUREMENT<$50K 60 | 9,712.4 |  | ELOUADRHIRI L | 1 | 1 |  | LATIFA E |  |  |  | 12-007 | 13-002F |  |  |  |  |  |  | 12-027 |  |  |  |  | IN | APP |  |  |  |  |
| 142242135a |  | Gas Window Design FY13 |  | 12d | 2012-10-01 | 2012-10-16 | 142242135 | 236d |  |  | MECH DES [5.58 h]; SCIENTIST [2.79 h]; VISTNG USERS [2.79 h] | 536.32 |  | ELOUADRHIRI L | 1 | 1 |  | LATIFA E |  |  |  | 12-007 | 13-002F |  |  |  |  |  |  |  |  |  | 12-053 |  | IN | APP |  |  |  |  |
| 142242145a |  | Complete Design Box Walls FY13 |  | 6d | 2012-10-01 | 2012-10-08 | 142242145 | 126d | 85d |  | VISTNG USERS [1.91 h]; MECH DES [7.48 h]; SCIENTIST [1.91 h] | 549.09 |  | ELOUADRHIRI L | 1 | 1 |  | LATIFA E |  |  |  | 12-007 | 13-002F |  |  |  |  |  |  |  |  |  | 12-053 |  | IN | APP |  |  |  |  |
| 142242165a |  | Procure Cables FY13 |  | 58d | 2012-10-01 | 2012-12-21 | 142242165 | 190d |  |  | SCIENTIST [16.93 h]; VISTNG USERS [16.93 h] | 1,571.27 |  | ELOUADRHIRI L | 1 | 1 |  | LATIFA E |  |  |  | 12-007 | 13-002F |  |  |  |  |  |  |  |  |  | 12-053 |  | IN | APP |  |  |  |  |
| 142242170 |  | Procure PMTs |  | 171d | 2012-10-01 | 2013-06-11 | 9-130M | 53d | 0d |  | PROCUREMENT<$50K 60; PROCUREMENT>$50K 69; SCIENTIST [40 h]; VISTNG USERS [40 h] | 133,731.8 |  | ELOUADRHIRI L | 1 | 1 |  | LATIFA E |  |  |  | 12-007 | 13-002F |  |  |  |  |  |  |  |  |  |  |  | IN | APP |  |  |  |  |
| 142242180a |  | Gas Line Design FY13 |  | 67d | 2012-10-01 | 2013-01-11 | 142242180 | 54d | 0d |  | MECH DES [124.65 h]; SCIENTIST [31.16 h]; VISTNG USERS [31.16 h] | 9,088.31 |  | ELOUADRHIRI L | 1 | 1 |  | LATIFA E |  |  |  | 12-007 | 13-002F |  |  |  |  |  |  |  |  |  | 12-053 |  | IN | APP |  |  |  |  |
| 142242220a |  | Online Calibration Design FY13 |  | 125d | 2012-10-01 | 2013-04-05 | 142242220 | 20d | 0d |  | SCIENTIST [162.99 h]; VISTNG USERS [130.51 h] | 14,479.12 |  | ELOUADRHIRI L | 1 | 1 |  | LATIFA E |  |  |  | 12-007 | 13-002F |  |  |  |  |  |  |  |  |  | 12-053 |  | IN | APP |  |  |  |  |
| 142242210 |  | Transport of FADC, DAQ, Computer, Electronics for 1 Sector |  | 37d | 2012-11-05 | 2013-01-04 | 9-130M FS+25d | 139d | 0d |  | MECH TECH [40 h]; SCIENTIST [40 h] | 4,748.8 |  | ELOUADRHIRI L | 1 | 1 |  | LATIFA E |  |  |  | 12-007 | 13-002F |  |  |  |  |  |  |  |  |  |  |  | IN | APP |  |  |  |  |
| 142242095 |  | Create Manufacturing Drawings |  | 64d | 2013-01-03 | 2013-04-04 | 9-130M FS+60d, 142242090 FS+7d | 42d | 22d |  | MECH DES [160 h] | 7,953.6 |  | ELOUADRHIRI L | 1 | 1 |  | LATIFA E |  |  |  | 12-007 | 13-002F |  |  |  |  |  |  |  |  |  | 12-053 | 12-054 | IN | APP |  |  |  |  |
| 142242100 |  | Removal of mirrors |  | 82d | 2013-01-03 | 2013-04-30 | 9-130M FS+60d, 142242090 FS-2d | 20d | 0d |  | VISTNG USERS [20 h]; MECH TECH [40 h]; SCIENTIST [20 h] | 3,690.6 |  | ELOUADRHIRI L | 1 | 1 |  | LATIFA E |  |  |  | 12-007 | 13-002F |  |  |  |  |  |  |  |  |  | 12-053 | 12-054 | IN | APP |  |  |  |  |
| 142242055 |  | Alignment Tool and Lasers Installation |  | 16d | 2013-01-16 | 2013-02-07 | 142242050 FS-10d, 142242045 FS-10d | 20d | 0d |  | MECH TECH [20 h]; SCIENTIST [20 h] | 2,374.4 |  | ELOUADRHIRI L | 1 | 1 |  | LATIFA E |  |  |  | 12-007 | 13-002F |  |  |  |  |  |  | 12-027 |  |  |  |  | IN | APP |  |  |  |  |
| 142242185 |  | Procure Gas Line |  | 92d | 2013-01-22 | 2013-05-31 | 142242180a FS+5d | 54d | 0d |  | SCIENTIST [40 h]; PROCUREMENT<$50K 60 | 7,042 |  | ELOUADRHIRI L | 1 | 1 |  | LATIFA E |  |  |  | 12-007 | 13-002F |  |  |  |  |  |  |  |  |  |  |  | IN | APP |  |  |  |  |
| 142242215 |  | Installation of FADC, DAQ, Computer, Electronics for 1 Sector |  | 36d | 2013-01-23 | 2013-03-14 | 142242210 FS+11d | 139d |  |  |  |  |  | ELOUADRHIRI L | 1 | 1 |  | LATIFA E |  |  |  | 12-007 | 13-002F |  |  |  |  |  |  |  |  |  |  |  | IN | APP |  |  |  |  |
| 142242060 |  | Alignment Tool and Lasers Quality Control |  | 23d | 2013-02-14 | 2013-03-19 | 142242055 FS+4d | 136d |  |  | SCIENTIST [40 h]; VISTNG USERS [40 h] | 3,712.4 |  | ELOUADRHIRI L | 1 | 1 |  | LATIFA E |  |  |  | 12-007 | 13-002F |  |  |  |  |  |  | 12-027 |  |  |  |  | IN | APP |  |  |  |  |
| 142242175 |  | PMTs Quality Control |  | 99d | 2013-02-26 | 2013-07-16 | 142242170 FS-75d | 53d |  |  | SCIENTIST [40 h]; VISTNG USERS [40 h] | 3,712.4 |  | ELOUADRHIRI L | 1 | 1 |  | LATIFA E |  |  |  | 12-007 | 13-002F |  |  |  |  |  |  |  |  |  |  |  | IN | APP |  |  |  |  |
| 142242150 |  | PMTs Removal |  | 77d | 2013-03-04 | 2013-06-19 | 142242145a FS+9d, 9-130M FS+100d | 41d | 0d |  | MECH TECH [80 h] | 3,668.8 |  | ELOUADRHIRI L | 1 | 1 |  | LATIFA E |  |  |  | 12-007 | 13-002F |  |  |  |  |  |  |  |  |  |  | 12-054 | IN | APP |  |  |  |  |
| 142242155 |  | Walls Manufacturing and Installation |  | 79d | 2013-04-11 | 2013-08-01 | 142242150 FS-49d, 142242145a | 41d |  |  | MECH TECH [40 h]; MSHOP | 15,249.1 |  | ELOUADRHIRI L | 1 | 1 |  | LATIFA E |  |  |  | 12-007 | 13-002F |  |  |  |  |  |  |  |  |  |  | 12-054 | IN | APP |  |  |  |  |
| 142242200 |  | Elliptical Mirror Tool/Frame Alignment |  | 22d | 2013-05-07 | 2013-06-06 | 142242055 FS+61d, 142242080, 142242095 | 20d | 0d |  | MECH TECH [40 h]; MECH DES [40 h] | 3,822.8 |  | ELOUADRHIRI L | 1 | 1 |  | LATIFA E |  |  |  | 12-007 | 13-002F |  |  |  |  |  |  | 12-027 |  |  |  |  | IN | APP |  |  |  |  |
| 142242105 |  | Al/Mg Deposit Procurement Prep |  | 43d | 2013-05-10 | 2013-07-11 | 142242100 FS+7d | 20d | 0d |  | SCIENTIST [80 h] | 5,828.8 |  | ELOUADRHIRI L | 1 | 1 |  | LATIFA E |  |  |  | 12-007 | 13-002F |  |  |  |  |  |  |  |  |  |  | 12-054 | IN | APP |  |  |  |  |
| 142242190 |  | Install Gas Line |  | 15d | 2013-05-20 | 2013-06-10 | 142242185 FS-9d | 54d | 0d |  | MECH TECH [80 h] | 3,668.8 |  | ELOUADRHIRI L | 1 | 1 |  | LATIFA E |  |  |  | 12-007 | 13-002F |  |  |  |  |  |  |  |  |  |  |  | IN | APP |  |  |  |  |
| 142242225 |  | Online Calibration Test |  | 73d | 2013-05-20 | 2013-08-30 | 142242220a FS+30d | 20d |  |  | SCIENTIST [69.53 h]; VISTNG USERS [69.53 h] | 6,452.61 |  | ELOUADRHIRI L | 1 | 1 |  | LATIFA E |  |  |  | 12-007 | 13-002F |  |  |  |  |  |  |  |  |  |  |  | IN | APP |  |  |  | 13-014 |

Notes:
- 242241405b: Steps: Installation of 12 Half-sectors without gluing them together; Gluing 6 Half-sectors together; Gluing of remaining 6 Half-sectors together; Gluing of the First and Second halfs together; Installation of the ring with bridge pieces glued to the ring; Gluing of the ring with bridge pieces to the mirror
- 242241410: Steps: Installation of the testing equipment; Quality control and tests of all Half-sectors
- 242241605: Steps: Dry fit and alignment of the carbon cone with spokes in CV; Final assembly of the cone in the Containment Vessel
- 242241610: Steps: Preparation of the exit window for installation; Dry fit of the exit window to the CV with carbon cone installed; Gluing of the window to the CV
- 242241647d5: Steps: Light leak tests and fixing possible leaks; Gas leak tests of CV and fixing possible leaks
- 242241640: Steps: Installation of the mounting fixtures in the CV; Preparation of the Mirror for lifting off the table; Installation of the mMirror in the CV; Alignment of the Mirror and geometry tests

| ID | Activity | Duration | Start | Finish | Predecessors | Total float | Free float | Calendar | Resources | Cost | PHAS - Project Phase | RESP - Responsibility | STRT%COMP for CM EVM | FNSH%COMP for CM EVM | Advance Purchase Plan > 500K | CAM RESPONSIBLE | CR 12-007 | CR 12-027 | CR 13-002 | CR 13-014 | CR 12-054 | ReBaseline Actuals Adjustment | Original Activity ID Rebaseline | EVMS Reporting Codes | BOE Labor | BOE Expenses | CR 13-015 | Post Rebaseline | BOE Procurement | CR 12-053 | Activities with Steps | CR 14-001 |
| --- | --- | --- | --- | --- | --- | --- | --- | --- | --- | --- | --- | --- | --- | --- | --- | --- | --- | --- | --- | --- | --- | --- | --- | --- | --- | --- | --- | --- | --- | --- | --- | --- |
| 142242205 | Mirrors Laser Alignments | 57d | 2013-06-12 | 2013-08-30 | 142242200 FS+3d | 20d |  |  | MECH TECH [70.57 h]; SCIENTIST [105.86 h]; VISTNG USERS [105.86 h] | 13,061.2 | IN | ELOUADRHIRI L | 1 | 1 | APP | LATIFA E | 12-007 | 12-027 | 13-002F | 13-014 |  |  |  |  |  |  |  |  |  |  |  |  |
| 142242195 | Gas Line Quality Control | 15d | 2013-06-24 | 2013-07-15 | 142242190 FS+9d | 54d |  |  | MECH TECH [40 h] | 1,834.4 | IN | ELOUADRHIRI L | 1 | 1 | APP | LATIFA E | 12-007 |  | 13-002F |  |  |  |  |  |  |  |  |  |  |  |  |  |
| 142242110 | Al/Mg Deposit Procurement | 26d | 2013-07-26 | 2013-08-30 | 142242105 FS+10d | 20d |  |  | PROCUREMENT>$50K 69 NO ESCALATION FY14; MECH TECH [10.3 h]; PROCUREMENT<$50K 60 NO ESCALATION FY14 | 472.36 | IN | ELOUADRHIRI L | 1 | 1 | APP | LATIFA E | 12-007 |  | 13-002F | 13-014 | 12-054 |  |  |  |  |  |  |  |  |  |  |  |
| 142242245 | Re-Baseline Actuals Adjustment | 1d | 2013-08-30 | 2013-08-30 | 9-130M FS+227d | 20d |  |  | PROCUREMENT>$50K 69 NO ESCALATION | -25,767.92 |  | ELOUADRHIRI L | 1 | 1 |  | LATIFA E |  |  |  | 13-014 |  | ADJ |  |  |  |  |  |  |  |  |  |  |
| 242242036 | Wavelength Shifting tests Labor/Expenses FY13 | 20d | 2013-09-03 | 2013-09-30 | 9-130M FS+228d | 252d | 0d | 8/5 M-F w/JLAB Holidays ReBaseline | SUPPLIES & MATERIALS; SCIENTIST [18.06 h] | 2,606.17 | IN | ELOUADRHIRI L | 1 | 1 | APP | LATIFA E | 12-007 |  | 13-002F |  |  |  | 242242036 | H | PE | PE | 13-015 | PR |  |  |  |  |
| 242242045 | Procurement Lasers - Procurement | 95d | 2013-09-03 | 2014-01-28 | 9-130M FS+228d | 216d | 0d | 8/5 M-F w/JLAB Holidays ReBaseline | SCIENTIST; PROCUREMENT<$50K 60 NO ESCALATION FY14 | 1,651.04 | IN | ELOUADRHIRI L | 1 | 1 | APP | LATIFA E | 12-007 | 12-027 | 13-002F |  |  |  | 242242045 | D | PE |  | 13-015 | PR | PE |  |  |  |
| 242242045a | Procurement Lasers - Labor FY13 | 20d | 2013-09-03 | 2013-09-30 | 9-130M FS+228d | 216d | 0d | 8/5 M-F w/JLAB Holidays ReBaseline | SCIENTIST [0.51 h] | 37.16 | IN | ELOUADRHIRI L | 1 | 1 | APP | LATIFA E | 12-007 | 12-027 | 13-002F |  |  |  | 242242045 | D | PE |  | 13-015 | PR | PE |  |  |  |
| 242242095 | Create Manufacturing Drawings FY13 | 20d | 2013-09-03 | 2013-09-30 | 9-130M FS+228d | 249d | 0d | 8/5 M-F w/JLAB Holidays ReBaseline | SCIENTIST [1.71 h] | 124.59 | IN | ELOUADRHIRI L | 1 | 1 | APP | LATIFA E | 12-007 |  | 13-002F |  | 12-054 |  | 242242095 | H | PE |  | 13-015 | PR |  | 12-053 |  |  |
| 242242105 | Al/Mg Deposit Procurement Prep FY13 | 20d | 2013-09-03 | 2013-09-30 | 9-130M FS+228d | 220d | 0d | 8/5 M-F w/JLAB Holidays ReBaseline | SCIENTIST [6.15 h] | 448.09 | IN | ELOUADRHIRI L | 1 | 1 | APP | LATIFA E | 12-007 |  | 13-002F |  | 12-054 |  | 242242105 | H | PE |  | 13-015 | PR |  |  |  |  |
| 242242145a | Complete Design Box Walls FY13 | 20d | 2013-09-03 | 2013-09-30 | 9-130M FS+228d | 467d | 0d | 8/5 M-F w/JLAB Holidays ReBaseline | SCIENTIST [2.22 h] | 161.75 | IN | ELOUADRHIRI L | 1 | 1 | APP | LATIFA E | 12-007 |  | 13-002F |  |  |  | 242242145a | H | PE |  | 13-015 | PR |  | 12-053 |  |  |
| 242242152 | Window Procurement | 139d | 2013-09-03 | 2014-03-31 | 9-130M FS+228d | 185d | 0d | 8/5 M-F w/JLAB Holidays ReBaseline | SCIENTIST; PROCUREMENT<$50K 60 NO ESCALATION FY14 | 2,800 | IN | ELOUADRHIRI L | 1 | 1 | APP | LATIFA E | 12-007 |  | 13-002F |  | 12-054 |  | 242242152 | D | PE |  | 13-015 | PR | PE |  |  |  |
| 242242152a | Window Procurement - Labor FY13 | 20d | 2013-09-03 | 2013-09-30 | 9-130M FS+228d | 185d | 0d | 8/5 M-F w/JLAB Holidays ReBaseline | SCIENTIST [4.6 h] | 335.16 | IN | ELOUADRHIRI L | 1 | 1 | APP | LATIFA E | 12-007 |  | 13-002F |  | 12-054 |  | 242242152 | D | PE |  | 13-015 | PR | PE |  |  |  |
| 242242220a | Online Calibration Design FY13 | 20d | 2013-09-03 | 2013-09-30 | 9-130M FS+228d | 239d | 0d | 8/5 M-F w/JLAB Holidays ReBaseline | SCIENTIST [3.96 h] | 288.53 | IN | ELOUADRHIRI L | 1 | 1 | APP | LATIFA E | 12-007 |  | 13-002F |  |  |  | 242242220a | S | PE |  | 13-015 | PR |  | 12-053 | ST |  |
| 242242222 | Online HV Matching Design FY13 | 20d | 2013-09-03 | 2013-09-30 | 242242220aa FS-202d, 242242220a FS-202d | 239d | 0d | 8/5 M-F w/JLAB Holidays ReBaseline | SCIENTIST [4.36 h] | 317.67 | IN | ELOUADRHIRI L | 1 | 1 | APP | LATIFA E | 12-007 |  | 13-002F |  |  |  | 242242222 | S | PE |  | 13-015 | PR |  | 12-053 | ST |  |
| 242242290 | Cut Line Mark | 20d | 2013-09-03 | 2013-09-30 | 9-130M FS+228d | 382d | 0d | 8/5 M-F w/JLAB Holidays ReBaseline | MECH TECH [12.8 h] | 587.01 | IN | ELOUADRHIRI L | 1 | 1 | APP | LATIFA E | 12-007 | 12-027 | 13-002F |  | 12-054 |  | 242242290 | H | PE |  | 13-015 | PR |  |  |  |  |
| 242242325 | Spine Refusrbish FY13 | 20d | 2013-09-03 | 2013-09-30 | 242242320 FS-289d, 242242315 FS-289d | 255d | 0d | 8/5 M-F w/JLAB Holidays ReBaseline | MECH TECH [1.42 h] | 65.12 | IN | ELOUADRHIRI L | 1 | 1 | APP | LATIFA E | 12-007 | 12-027 | 13-002F |  | 12-054 |  | 242242325 | H | PE |  | 13-015 | PR |  |  |  |  |
| 242242031 | Quality Control of Existing PMTs FY13 | 15d | 2013-09-10 | 2013-09-30 | 9-130M FS+233d | 248d | 0d | 8/5 M-F w/JLAB Holidays ReBaseline | CONTRB UNIV LBR [19.57 h]; VISTNG USERS [13.04 h]; SCIENTIST [0.98 h] | 331.52 | IN | ELOUADRHIRI L | 1 | 1 | APP | LATIFA E | 12-007 |  | 13-002F |  |  |  | 242242031 | U | PE |  | 13-015 | PR |  |  |  |  |
| 242242107 | Al/Mg Laxon/Acrylic Re-Coating Test Procurement Labor FY13 | 15d | 2013-09-10 | 2013-09-30 | 9-130M FS+233d | 236d | 0d | 8/5 M-F w/JLAB Holidays ReBaseline | SCIENTIST [8 h] | 582.88 | IN | ELOUADRHIRI L | 1 | 1 | APP | LATIFA E | 12-007 |  | 13-002F |  | 12-054 |  | 242242107 | H | PE |  | 13-015 | PR |  |  |  |  |
| 242242280 | Frame Support FY13 | 9d | 2013-09-18 | 2013-09-30 | 9-130M FS+239d | 470d | 0d | 8/5 M-F w/JLAB Holidays ReBaseline | MECH TECH [2.62 h] | 120.15 | IN | ELOUADRHIRI L | 1 | 1 | APP | LATIFA E | 12-007 | 12-027 | 13-002F |  | 12-054 |  | 242242280 | H | PE |  | 13-015 | PR |  |  |  |  |
| 242242050 | Alignment Tool Manufacturing Labor/Expenses FY13 | 7d | 2013-09-20 | 2013-09-30 | 9-130M FS+241d | 217d | 0d | 8/5 M-F w/JLAB Holidays ReBaseline | MECH TECH [4.75 h]; MSHOP | 751.74 | IN | ELOUADRHIRI L | 1 | 1 | APP | LATIFA E | 12-007 |  | 13-002F |  |  |  | 242242050 | D | PE | PE | 13-015 | PR |  |  |  |  |
| 242242295 | Wall Cut-Off FY13 | 1d | 2013-09-30 | 2013-09-30 | 242242290 FS-1d | 382d | 0d | 8/5 M-F w/JLAB Holidays ReBaseline | MECH TECH [0.12 h] | 5.5 | IN | ELOUADRHIRI L | 1 | 1 | APP | LATIFA E | 12-007 | 12-027 | 13-002F |  | 12-054 |  | 242242295 | H | PE |  | 13-015 | PR |  |  |  |  |
| 242242031a | Quality Control of Existing PMTs FY14 | 169d | 2013-10-01 | 2014-06-10 | 9-130M FS+233d, 242242031 | 248d | 0d | 8/5 M-F w/JLAB Holidays ReBaseline | CONTRB UNIV LBR [220.43 h]; VISTNG USERS [146.96 h]; SCIENTIST [11.02 h] | 3,854.42 | IN | ELOUADRHIRI L | 1 | 1 | APP | LATIFA E | 12-007 |  | 13-002F |  |  |  | 242242031 | U | PE |  | 13-015 | PR |  |  |  | 14-001 |
| 242242036a | Wavelength Shifting tests Labor/Expenses FY14 | 11d | 2013-10-01 | 2013-10-15 | 9-130M FS+228d, 242242036 | 252d | 0d | 8/5 M-F w/JLAB Holidays ReBaseline | SUPPLIES & MATERIALS; SCIENTIST [9.94 h] | 1,479.61 | IN | ELOUADRHIRI L | 1 | 1 | APP | LATIFA E | 12-007 |  | 13-002F |  |  |  | 242242036 | H | PE | PE | 13-015 | PR |  |  |  | 14-001 |
| 242242045b | Procurement Lasers - Labor FY14 | 75d | 2013-10-01 | 2014-01-28 | 9-130M FS+228d, 242242045a | 216d | 0d | 8/5 M-F w/JLAB Holidays ReBaseline | SCIENTIST [1.89 h] | 142.09 | IN | ELOUADRHIRI L | 1 | 1 | APP | LATIFA E | 12-007 | 12-027 | 13-002F |  |  |  | 242242045 | D | PE |  | 13-015 | PR | PE |  |  | 14-001 |
| 242242050a | Alignment Tool Manufacturing Labor/Expenses FY14 | 52d | 2013-10-01 | 2013-12-13 | 242242050, 9-130M FS+241d | 217d | 1d | 8/5 M-F w/JLAB Holidays ReBaseline | MECH TECH [35.25 h]; MSHOP | 5,760.65 | IN | ELOUADRHIRI L | 1 | 1 | APP | LATIFA E | 12-007 |  | 13-002F |  |  |  | 242242050 | D | PE | PE | 13-015 | PR |  |  |  | 14-001 |
| 242242095a | Create Manufacturing Drawings FY14 | 8d | 2013-10-01 | 2013-10-10 | 242242095, 9-130M FS+228d | 249d | 0d | 8/5 M-F w/JLAB Holidays ReBaseline | SCIENTIST [0.69 h] | 51.87 | IN | ELOUADRHIRI L | 1 | 1 | APP | LATIFA E | 12-007 |  | 13-002F |  | 12-054 |  | 242242095 | H | PE |  | 13-015 | PR |  | 12-053 |  | 14-001 |
| 242242105a | Al/Mg Deposit Procurement Prep FY14 | 6d | 2013-10-01 | 2013-10-08 | 242242105, 9-130M FS+228d | 220d | 0d | 8/5 M-F w/JLAB Holidays ReBaseline | SCIENTIST [1.85 h] | 139.08 | IN | ELOUADRHIRI L | 1 | 1 | APP | LATIFA E | 12-007 |  | 13-002F |  | 12-054 |  | 242242105 | H | PE |  | 13-015 | PR |  |  |  | 14-001 |
| 242242107a | Al/Mg Laxon/Acrylic Re-Coating Test Procurement Labor FY14 | 30d | 2013-10-01 | 2013-11-11 | 9-130M FS+233d, 242242107 | 236d | 0d | 8/5 M-F w/JLAB Holidays ReBaseline | SCIENTIST [16 h] | 1,202.88 | IN | ELOUADRHIRI L | 1 | 1 | APP | LATIFA E | 12-007 |  | 13-002F |  | 12-054 |  | 242242107 | H | PE |  | 13-015 | PR |  |  |  | 14-001 |
| 242242145aa | Complete Design Box Walls FY14 | 16d | 2013-10-01 | 2013-10-22 | 242242145a, 9-130M FS+228d | 467d | 0d | 8/5 M-F w/JLAB Holidays ReBaseline | SCIENTIST [1.78 h] | 133.82 | IN | ELOUADRHIRI L | 1 | 1 | APP | LATIFA E | 12-007 |  | 13-002F |  |  |  | 242242145a | H | PE |  | 13-015 | PR |  | 12-053 |  | 14-001 |
| 242242152b | Window Procurement -Labor FY14 | 119d | 2013-10-01 | 2014-03-31 | 9-130M FS+228d, 242242152a | 185d | 0d | 8/5 M-F w/JLAB Holidays ReBaseline | SCIENTIST [27.4 h] | 2,059.93 | IN | ELOUADRHIRI L | 1 | 1 | APP | LATIFA E | 12-007 |  | 13-002F |  | 12-054 |  | 242242152 | D | PE |  | 13-015 | PR | PE |  |  | 14-001 |
| 242242220aa | Online Calibration Design FY14 | 182d | 2013-10-01 | 2014-06-27 | 242242220a, 9-130M FS+228d | 239d | 0d | 8/5 M-F w/JLAB Holidays ReBaseline | SCIENTIST [36.04 h] | 2,709.49 | IN | ELOUADRHIRI L | 1 | 1 | APP | LATIFA E | 12-007 |  | 13-002F |  |  |  | 242242220a | S | PE |  | 13-015 | PR |  | 12-053 | ST | 14-001 |
| 242242222a | Online HV Matching Design FY14 | 182d | 2013-10-01 | 2014-06-27 | 242242220aa FS-202d, 242242222, 242242220a FS-202d | 239d | 0d | 8/5 M-F w/JLAB Holidays ReBaseline | SCIENTIST [39.64 h] | 2,980.14 | IN | ELOUADRHIRI L | 1 | 1 | APP | LATIFA E | 12-007 |  | 13-002F |  |  |  | 242242222 | S | PE |  | 13-015 | PR |  | 12-053 | ST | 14-001 |
| 242242245 | Simulation of Sagging Test | 100d | 2013-10-01 | 2014-03-04 | 9-140M | 383d | 0d | 8/5 M-F w/JLAB Holidays ReBaseline | SCIENTIST [24 h] | 1,804.32 | IN | ELOUADRHIRI L | 1 | 1 | APP | LATIFA E | 12-007 | 12-027 | 13-002F |  | 12-054 |  | 242242245 | H | PE |  | 13-015 | PR |  |  |  | 14-001 |
| 242242280a | Frame Support FY14 | 46d | 2013-10-01 | 2013-12-05 | 9-130M FS+239d, 242242280 | 470d | 285d | 8/5 M-F w/JLAB Holidays ReBaseline | MECH TECH [13.38 h] | 633.14 | IN | ELOUADRHIRI L | 1 | 1 | APP | LATIFA E | 12-007 | 12-027 | 13-002F |  | 12-054 |  | 242242280 | H | PE |  | 13-015 | PR |  |  |  | 14-001 |
| 242242295a | Wall Cut-Off FY14 | 134d | 2013-10-01 | 2014-04-21 | 242242295, 242242290 FS-1d | 382d | 197d | 8/5 M-F w/JLAB Holidays ReBaseline | MECH TECH [15.88 h] | 751.44 | IN | ELOUADRHIRI L | 1 | 1 | APP | LATIFA E | 12-007 | 12-027 | 13-002F |  | 12-054 |  | 242242295 | H | PE |  | 13-015 | PR |  |  |  | 14-001 |
| 242242325a | Spine Refusrbish FY14 | 261d | 2013-10-01 | 2014-10-20 | 242242325, 242242320 FS-289d, 242242315 FS-289d | 255d | 0d | 8/5 M-F w/JLAB Holidays ReBaseline | MECH TECH [18.58 h] | 879.21 | IN | ELOUADRHIRI L | 1 | 1 | APP | LATIFA E | 12-007 | 12-027 | 13-002F |  | 12-054 |  | 242242325 | H | PE |  | 13-015 | PR |  |  |  | 14-001 |
| 242242310 | PMTS, Mirrors Holes Drill | 213d | 2013-10-08 | 2014-08-19 | 242242305 FS-200d | 249d | 1d | 8/5 M-F w/JLAB Holidays ReBaseline | MECH TECH [16 h] | 757.12 | IN | ELOUADRHIRI L | 1 | 1 | APP | LATIFA E | 12-007 | 12-027 | 13-002F |  | 12-054 |  | 242242310 | H | PE |  | 13-015 | PR |  |  |  | 14-001 |
| 242242030 | Quality Control of PMTs | 162d | 2013-10-10 | 2014-06-10 | 9-140M FS+7d | 347d | 162d | 8/5 M-F w/JLAB Holidays ReBaseline | CONTRB UNIV LBR [120 h] |  | IN | ELOUADRHIRI L | 1 | 1 | APP | LATIFA E | 12-007 |  | 13-002F |  |  |  | 242242030 | Z | PE |  | 13-015 | PR |  |  |  |  |
| 242242155 | Walls Manufacturing and Installation | 39d | 2013-10-15 | 2013-12-10 | 242242145a FS-6d, 242242145aa FS-6d | 467d | 282d | 8/5 M-F w/JLAB Holidays ReBaseline | SCIENTIST [8 h]; MECH TECH [40 h] | 2,494.24 | IN | ELOUADRHIRI L | 1 | 1 | APP | LATIFA E | 12-007 |  | 13-002F |  | 12-054 |  | 242242155 | H | PE |  | 13-015 | PR |  |  |  | 14-001 |
| 242242340 | Sector 2 Box Refurbish | 28d | 2013-10-30 | 2013-12-10 | 9-140M FS+21d | 185d | 0d | 8/5 M-F w/JLAB Holidays ReBaseline | MECH TECH [320 h] | 15,142.4 | IN | ELOUADRHIRI L | 1 | 1 | APP | LATIFA E | 12-007 |  | 13-002F |  | 12-054F |  | 242242340 | S | PE |  | 13-015 | PR |  |  | ST | 14-001 |
| 242242085 | Quality Control of Elliptical/Hyperbolic mirrors | 178d | 2013-10-31 | 2014-07-24 | 9-140M FS+22d | 348d | 80d | 8/5 M-F w/JLAB Holidays ReBaseline | SCIENTIST [48 h]; VISTNG USERS [320 h] | 10,197.44 | IN | ELOUADRHIRI L | 1 | 1 | APP | LATIFA E | 12-007 |  | 13-002F |  | 12-054F |  | 242242085 | S | PE |  | 13-015 | PR |  |  | ST | 14-001 |
| 242242055 | Alignment Tool and Lasers Installation | 87d | 2013-11-01 | 2014-03-18 | 242242050a FS-30d, 242242045 FS-52d, 242242050 FS-30d, 242242045a FS-52d, 242242045b FS-52d | 216d | 0d | 8/5 M-F w/JLAB Holidays ReBaseline | MECH TECH [40 h]; SCIENTIST [8 h] | 2,494.24 | IN | ELOUADRHIRI L | 1 | 1 | APP | LATIFA E | 12-007 | 12-027 | 13-002F |  |  |  | 242242055 | S | PE |  | 13-015 | PR |  |  | ST | 14-001 |
| 242242335 | Box Refurbish Consumables | 281d | 2013-11-01 | 2014-12-22 | 9-140M FS+23d | 212d | 27d | 8/5 M-F w/JLAB Holidays ReBaseline | SUPPLIES & MATERIALS | 18,574.2 | IN | ELOUADRHIRI L | 1 | 1 | APP | LATIFA E | 12-007 |  | 13-002F |  | 12-054F |  | 242242335 | D |  | PE | 13-015 | PR |  |  |  | 14-001 |
| 242242300 | Rear Brace Manufacture | 74d | 2013-11-04 | 2014-02-28 | 242242095a FS+16d, 242242095 FS+16d | 249d | 0d | 8/5 M-F w/JLAB Holidays ReBaseline | MECH TECH [16 h]; SUPPLIES & MATERIALS | 1,273.07 | IN | ELOUADRHIRI L | 1 | 1 | APP | LATIFA E | 12-007 | 12-027 | 13-002F |  | 12-054 |  | 242242300 | H | PE | PE | 13-015 | PR |  |  |  | 14-001 |
| 242242108 | Lexan/Acrylic/Over- Coating Procurement (all sectors) | 241d | 2013-11-11 | 2014-10-31 | 242242107 FS-1d, 242242107a FS-1d | 246d | 61d | 8/5 M-F w/JLAB Holidays ReBaseline | SCIENTIST [44 h]; SUPPLIES & MATERIALS | 5,371.72 | IN | ELOUADRHIRI L | 1 | 1 | APP | LATIFA E | 12-007 |  | 13-002F |  | 12-054 |  | 242242108 | U | PE | PE | 13-015 | PR | PE |  |  | 14-001 |
| 242242110 | Al/Mg Deposit Procurement | 259d | 2013-11-11 | 2014-11-26 | 242242105 FS+23d, 242242105a FS+23d | 220d | 0d | 8/5 M-F w/JLAB Holidays ReBaseline | PROCUREMENT<$50K 60 NO ESCALATION FY15; PROCUREMENT>$50K 69 NO ESCALATION FY15 | 53,240.88 | IN | ELOUADRHIRI L | 1 | 1 | APP | LATIFA E | 12-007 |  | 13-002F |  | 12-054 |  | 242242110 | D |  |  | 13-015 | PR | PE |  |  | 14-001 |
| 242242161 | HV Cables Catalog and Tagging | 103d | 2013-11-12 | 2014-04-18 | 9-140M FS+30d | 311.5d | 0d | 8/5 M-F w/JLAB Holidays ReBaseline | MECH TECH [16 h] | 757.12 | IN | ELOUADRHIRI L | 1 | 1 | APP | LATIFA E | 12-007 |  | 13-002F |  | 12-054 |  | 242242161 | H | PE |  | 13-015 | PR |  |  |  | 14-001 |
| 242242162 | Divider Modifications Design and Test | 55d | 2013-11-12 | 2014-02-11 | 9-130M FS+228d, 9-140M FS+30d | 226d | 0d | 8/5 M-F w/JLAB Holidays ReBaseline | SUPPLIES & MATERIALS; SCIENTIST [8 h] | 1,633.34 | IN | ELOUADRHIRI L | 1 | 1 | APP | LATIFA E | 12-007 |  | 13-002F |  | 12-054 |  | 242242162 | H | PE | PE | 13-015 | PR |  |  |  | 14-001 |
| 242242165b | Procure Cables Procurement | 149d | 2013-11-12 | 2014-06-24 | 9-140M FS+30d | 337d | 152d | 8/5 M-F w/JLAB Holidays ReBaseline | SCIENTIST [32 h]; PROCUREMENT<$50K 60 | 24,240.76 | IN | ELOUADRHIRI L | 1 | 1 | APP | LATIFA E | 12-007 |  | 13-002F |  |  |  | 242242165b | D | PE |  | 13-015 | PR | PE | 12-053 |  | 14-001 |
| 242242092 | Al/Mg Deposit Procurement WC | 245d | 2013-11-19 | 2014-11-14 | 242242107a FS+5d, 242242107 FS+5d | 236d | 51d | 8/5 M-F w/JLAB Holidays ReBaseline | SCIENTIST [88 h]; PROCUREMENT<$50K 60 NO ESCALATION FY15; PROCUREMENT>$50K 69 NO ESCALATION FY15 | 59,856.72 | IN | ELOUADRHIRI L | 1 | 1 | APP | LATIFA E | 12-007 |  | 13-002F |  | 12-054F |  | 242242092 | U | PE |  | 13-015 | PR | PE |  |  | 14-001 |
| 242242137 | Glue Procurement | 74d | 2013-12-05 | 2014-03-31 | 9-140M FS+45d | 397d | 212d | 8/5 M-F w/JLAB Holidays ReBaseline | SCIENTIST [4 h]; SUPPLIES & MATERIALS | 2,381.03 | IN | ELOUADRHIRI L | 1 | 1 | APP | LATIFA E | 12-007 |  | 13-002F |  |  |  | 242242137 | D | PE | PE | 13-015 | PR |  | 12-053 |  | 14-001 |
| 242242255 | Procurement Sagging Test Tools | 52d | 2014-01-03 | 2014-03-18 | 242242245 FS-42d | 383d | 0d | 8/5 M-F w/JLAB Holidays ReBaseline | SCIENTIST [8 h] | 601.44 | IN | ELOUADRHIRI L | 1 | 1 | APP | LATIFA E | 12-007 | 12-027 | 13-002F |  | 12-054 |  | 242242255 | D | PE |  | 13-015 | PR |  |  |  | 14-001 |
| 242242260 | Manufacture Sagging Test Tools | 52d | 2014-01-03 | 2014-03-18 | 242242245 FS-42d | 383d | 0d | 8/5 M-F w/JLAB Holidays ReBaseline | MECH TECH [40 h] | 1,892.8 | IN | ELOUADRHIRI L | 1 | 1 | APP | LATIFA E | 12-007 | 12-027 | 13-002F |  | 12-054 |  | 242242260 | H | PE |  | 13-015 | PR |  |  |  | 14-001 |
| 242242076 | Support Frame Fabrication for 1S in TED | 61d | 2014-01-07 | 2014-04-02 | 9-140M FS+60d | 395d | 210d | 8/5 M-F w/JLAB Holidays ReBaseline | SUPPLIES & MATERIALS; MECH TECH [40 h] | 2,924.7 | IN | ELOUADRHIRI L | 1 | 1 | APP | LATIFA E | 12-007 |  | 13-002F |  | 12-054F |  | 242242076 | D | PE | PE | 13-015 | PR |  |  |  | 14-001 |
| 242242077 | Infrastructure Consumables | 162d | 2014-01-07 | 2014-08-25 | 9-140M FS+60d | 294d | 109d | 8/5 M-F w/JLAB Holidays ReBaseline | SUPPLIES & MATERIALS | 16,716.78 | IN | ELOUADRHIRI L | 1 | 1 | APP | LATIFA E | 12-007 |  | 13-002F |  | 12-054F |  | 242242077 | D |  | PE | 13-015 | PR |  |  |  | 14-001 |
| 242242090 | Dimensions check of Elliptical/Hyperbolic mirrors | 188d | 2014-01-07 | 2014-10-01 | 242242085 FS-220d, 9-140M FS+60d | 268d | 83d | 8/5 M-F w/JLAB Holidays ReBaseline | SCIENTIST [67.2 h]; VISTNG USERS [224 h] | 9,664.26 | IN | ELOUADRHIRI L | 1 | 1 | APP | LATIFA E | 12-007 |  | 13-002F |  | 12-054F |  | 242242090 | U | PE |  | 13-015 | PR |  |  |  | 14-001 |
| 242242040 | Wavelength Shifting Procurement | 203d | 2014-01-08 | 2014-10-23 | 242242036 FS+50d, 242242036a FS+50d | 252d | 67d | 8/5 M-F w/JLAB Holidays ReBaseline | PROCUREMENT<$50K 60 NO ESCALATION FY15; PROCUREMENT>$50K 69 NO ESCALATION FY15 | 61,914 | IN | ELOUADRHIRI L | 1 | 1 | APP | LATIFA E | 12-007 |  | 13-002F |  |  |  | 242242040 | D |  |  | 13-015 | PR | PE |  |  | 14-001 |
| 242242305 | Rear Brace Installation | 137d | 2014-01-17 | 2014-07-31 | 242242300 FS-30d | 249d | 0d | 8/5 M-F w/JLAB Holidays ReBaseline | MECH TECH [32 h] | 1,514.24 | IN | ELOUADRHIRI L | 1 | 1 | APP | LATIFA E | 12-007 | 12-027 | 13-002F |  | 12-054 |  | 242242305 | H | PE |  | 13-015 | PR |  |  |  | 14-001 |
| 242242115 | Installation of Elliptical mirrors | 227d | 2014-01-21 | 2014-12-10 | 242242110 FS-219d | 220d | 35d | 8/5 M-F w/JLAB Holidays ReBaseline | MECH TECH [16 h]; SCIENTIST [4 h] | 1,057.84 | IN | ELOUADRHIRI L | 1 | 1 | APP | LATIFA E | 12-007 |  | 13-002F |  | 12-054 |  | 242242115 | H | PE |  | 13-015 | PR |  |  |  | 14-001 |
| 242242230 | PMT Installation | 219d | 2014-01-21 | 2014-11-26 | 242242031 FS-100d, 242242310 FS-150d, 242242031a FS-100d | 248d | 0d | 8/5 M-F w/JLAB Holidays ReBaseline | SCIENTIST [4 h]; MECH TECH [16 h] | 1,057.84 | IN | ELOUADRHIRI L | 1 | 1 | APP | LATIFA E | 12-007 | 12-027 | 13-002F |  | 12-054 |  | 242242230 | H | PE |  | 13-015 | PR |  |  |  | 14-001 |
| 242242320 | Nose Extension Installation | 200d | 2014-01-21 | 2014-10-30 | 9-140M FS+69d | 255d | 0d | 8/5 M-F w/JLAB Holidays ReBaseline | MECH TECH [8 h] | 378.56 | IN | ELOUADRHIRI L | 1 | 1 | APP | LATIFA E | 12-007 | 12-027 | 13-002F |  | 12-054 |  | 242242320 | H | PE |  | 13-015 | PR |  |  |  | 14-001 |
| 242242365 | Sector 3 Box Refurbish | 21d | 2014-01-21 | 2014-02-18 | 242242360 FS-163d | 293d | 108d | 8/5 M-F w/JLAB Holidays ReBaseline | MECH TECH [288 h] | 13,628.16 | IN | ELOUADRHIRI L | 1 | 1 | APP | LATIFA E | 12-007 |  | 13-002F |  | 12-054F |  | 242242365 | S | PE |  | 13-015 | PR |  |  | ST | 14-001 |
| 242242205 | Mirrors Laser Alignments | 222d | 2014-02-03 | 2014-12-16 | 242242095, 242242055 FS-32d, 242242095a | 216d | 31d | 8/5 M-F w/JLAB Holidays ReBaseline | PD UNIV STUDNT [160 h]; MECH TECH [120 h]; SCIENTIST [104 h]; VISTNG USERS [160 h] | 18,609.12 | IN | ELOUADRHIRI L | 1 | 1 | APP | LATIFA E | 12-007 | 12-027 | 13-002F |  |  |  | 242242205 | S | PE |  | 13-015 | PR |  |  | ST | 14-001 |
| 242242315 | Patch Panel Installation | 185d | 2014-02-11 | 2014-10-30 | 242242230 FS-204d | 255d | 0d | 8/5 M-F w/JLAB Holidays ReBaseline | MECH TECH [8 h]; SCIENTIST [4 h] | 679.28 | IN | ELOUADRHIRI L | 1 | 1 | APP | LATIFA E | 12-007 | 12-027 | 13-002F |  | 12-054 |  | 242242315 | H | PE |  | 13-015 | PR |  |  |  | 14-001 |
| 242242169 | New Patch Panel Fabrication | 120d | 2014-02-11 | 2014-07-31 | 242242161 FS-48.5d | 311.5d | 126.5d | 8/5 M-F w/JLAB Holidays ReBaseline | MECH TECH [64 h] | 3,028.48 | IN | ELOUADRHIRI L | 1 | 1 | APP | LATIFA E | 12-007 |  | 13-002F |  |  |  | 242242169 | D | PE |  | 13-015 | PR |  | 12-053 |  | 14-001 |
| 242242163 | Divider Modifications Procurement | 220d | 2014-02-12 | 2014-12-23 | 242242162 | 226d | 0d | 8/5 M-F w/JLAB Holidays ReBaseline | SCIENTIST [32 h]; PROCUREMENT<$50K 60 NO ESCALATION FY15 | 6,017.41 | IN | ELOUADRHIRI L | 1 | 1 | APP | LATIFA E | 12-007 |  | 13-002F |  | 12-054 |  | 242242163 | D | PE |  | 13-015 | PR | PE |  |  | 14-001 |
| 242242164 | Divider Modifications Implementation | 205d | 2014-02-12 | 2014-12-02 | 242242163 FS-220d | 226d | 41d | 8/5 M-F w/JLAB Holidays ReBaseline | ELEC TECH [160 h]; SCIENTIST [44 h] | 10,826.32 | IN | ELOUADRHIRI L | 1 | 1 | APP | LATIFA E | 12-007 |  | 13-002F |  | 12-054 |  | 242242164 | U | PE |  | 13-015 | PR |  |  |  | 14-001 |
| 242242330 | Gas Line Refurbish | 165d | 2014-02-27 | 2014-10-20 | 242242325 FS-165d, 242242325a FS-165d | 255d | 70d | 8/5 M-F w/JLAB Holidays ReBaseline | MECH TECH [20 h]; SCIENTIST [4 h] | 1,247.12 | IN | ELOUADRHIRI L | 1 | 1 | APP | LATIFA E | 12-007 | 12-027 | 13-002F |  | 12-054 |  | 242242330 | H | PE |  | 13-015 | PR |  |  |  | 14-001 |
| 242242390 | Sector 4 Box Refurbish | 27d | 2014-03-03 | 2014-04-08 | 242242385 FS-170d | 301d | 116d | 8/5 M-F w/JLAB Holidays ReBaseline | MECH TECH [288 h] | 13,628.16 | IN | ELOUADRHIRI L | 1 | 1 | APP | LATIFA E | 12-007 |  | 13-002F |  | 12-054F |  | 242242390 | S | PE |  | 13-015 | PR |  |  | ST | 14-001 |
| 242242235 | Windows Installation 6 sectors | 197d | 2014-03-04 | 2014-12-10 | 242242152 FS-20d, 242242230 FS-252d, 242242152b FS-20d, 242242152a FS-20d | 185d | 0d | 8/5 M-F w/JLAB Holidays ReBaseline | MECH TECH [200 h] | 9,464 | IN | ELOUADRHIRI L | 1 | 1 | APP | LATIFA E | 12-007 | 12-027 | 13-002F |  | 12-054 |  | 242242235 | U | PE |  | 13-015 | PR |  |  |  | 14-001 |

Notes:
- 242242220a: Steps: HV slow control access; DAQ setup; Software to control HV; SPE Histos Software
- 242242222: Steps: HV slow control access; DAQ setup; Software to control HV; SPE Histos Software
- 242242220aa: Steps: HV slow control access; DAQ setup; Software to control HV; SPE Histos Software
- 242242222a: Steps: HV slow control access; DAQ setup; Software to control HV; SPE Histos Software
- 242242340: Steps: Box Frame Support; Cut Line Mark; Box Cut; Wall Cut; Box Plates Fit; Patch Panel Fit; Rear Brace; Nose Installation; PMT, Mirrors Holes; Spine Refurbish; Mount PMT, Mirrors, WC
- 242242085: Steps: Visual Inspection of Mirrors; Sample Mirrors Reflectivity Tests
- 242242055: Steps: Tool assembly; Laser table assembly; Laser system assembly; Sector mount on tool
- 242242365: Steps: Box Frame Support; Cut Line Mark; Box Cut; Wall Cut; Box Plates Fit; Patch Panel Fit; Rear Brace; Nose Installation; PMT, Mirrors Holes; Spine Refurbish; Mount PMT, Mirrors, WC
- 242242205: Steps: Laser Setup; Laser/Box Survey; Elliptical Alignment; Hyperbolic Alignment
- 242242390: Steps: Box Frame Support; Cut Line Mark; Box Cut; Wall Cut; Box Plates Fit; Patch Panel Fit; Rear Brace; Nose Installation; PMT, Mirrors Holes; Spine Refurbish; Mount PMT, Mirrors, WC

| ID | Activity | Type | Duration | Start | Finish | Predecessors | Total float | Free float | Calendar | Resources | Cost | Original Activity ID Rebaseline | PHAS - Project Phase | RESP - Responsibility | STRT%COMP for CM EVM | FNSH%COMP for CM EVM | Advance Purchase Plan > 500K | EVMS Reporting Codes | CAM RESPONSIBLE | Activities with Steps | CR 12-007 | CR 12-027 | CR 12-054 | CR 13-002 | BOE Labor | CR 13-015 | Post Rebaseline | CR 14-001 | CR 12-053 | BOE Procurement |
| --- | --- | --- | --- | --- | --- | --- | --- | --- | --- | --- | --- | --- | --- | --- | --- | --- | --- | --- | --- | --- | --- | --- | --- | --- | --- | --- | --- | --- | --- | --- |
| 242242270 | Sagging Test |  | 23d | 2014-03-19 | 2014-04-18 | 242242255, 242242260 | 383d | 198d | 8/5 M-F w/JLAB Holidays ReBaseline | MECH TECH [56 h]; SCIENTIST [12 h] | 3,552.08 | 242242270 | IN | ELOUADRHIRI L | 1 | 1 | APP | S | LATIFA E | ST | 12-007 | 12-027 | 12-054 | 13-002F | PE | 13-015 | PR | 14-001 |  |  |
| 242242415 | Sector 5 Box Refurbish |  | 22d | 2014-04-14 | 2014-05-13 | 242242410 FS-172d | 302d | 117d | 8/5 M-F w/JLAB Holidays ReBaseline | MECH TECH [256 h] | 12,113.92 | 242242415 | IN | ELOUADRHIRI L | 1 | 1 | APP | S | LATIFA E | ST | 12-007 |  | 12-054F | 13-002F | PE | 13-015 | PR | 14-001 |  |  |
| 242242350 | Sector 2 Mirrors Alignment |  | 50d | 2014-04-15 | 2014-06-24 | 242242340 FS+80d | 185d | 0d | 8/5 M-F w/JLAB Holidays ReBaseline | MECH TECH [80 h] | 3,785.6 | 242242350 | IN | ELOUADRHIRI L | 1 | 1 | APP | H | LATIFA E |  | 12-007 |  | 12-054F | 13-002F | PE | 13-015 | PR | 14-001 |  |  |
| 242242240 | Gas Leak Check 6 sectors |  | 174d | 2014-05-23 | 2015-02-10 | 242242235 FS-139d | 185d | 0d | 8/5 M-F w/JLAB Holidays ReBaseline | MECH TECH [120 h]; SCIENTIST [110 h] | 13,948.2 | 242242240 | IN | ELOUADRHIRI L | 1 | 1 | APP | S | LATIFA E | ST | 12-007 | 12-027 | 12-054 | 13-002F | PE | 13-015 | PR | 14-001 |  |  |
| 242242440 | Sector 6 Box Refurbish |  | 16d | 2014-05-27 | 2014-06-17 | 242242435 FS-158d | 300d | 115d | 8/5 M-F w/JLAB Holidays ReBaseline | MECH TECH [256 h] | 12,113.92 | 242242440 | IN | ELOUADRHIRI L | 1 | 1 | APP | S | LATIFA E | ST | 12-007 |  | 12-054F | 13-002F | PE | 13-015 | PR | 14-001 |  |  |
| 242242223 | Online HV Matching Test |  | 110d | 2014-06-09 | 2014-11-11 | 242242220aa FS-15d, 242242222 FS-15d, 242242220a FS-15d, 242242222a FS-15d | 239d | 0d | 8/5 M-F w/JLAB Holidays ReBaseline | SCIENTIST [48 h] | 3,608.64 | 242242223 | IN | ELOUADRHIRI L | 1 | 1 | APP | S | LATIFA E | ST | 12-007 |  |  | 13-002F | PE | 13-015 | PR | 14-001 | 12-053 |  |
| 242242355 | Sector 2 Windows Installation |  | 11d | 2014-06-30 | 2014-07-15 | 242242350 FS+3d | 185d | 0d | 8/5 M-F w/JLAB Holidays ReBaseline | MECH TECH [40 h] | 1,892.8 | 242242355 | IN | ELOUADRHIRI L | 1 | 1 | APP | H | LATIFA E |  | 12-007 |  | 12-054F | 13-002F | PE | 13-015 | PR | 14-001 |  |  |
| 242242375 | Sector 3 Mirrors Alignment |  | 26d | 2014-07-22 | 2014-08-26 | 242242355 FS+4d, 242242365 FS-1d | 185d | 0d | 8/5 M-F w/JLAB Holidays ReBaseline | MECH TECH [80 h] | 3,785.6 | 242242375 | IN | ELOUADRHIRI L | 1 | 1 | APP | H | LATIFA E |  | 12-007 |  | 12-054F | 13-002F | PE | 13-015 | PR | 14-001 |  |  |
| 242242360 | Sector 2 Gas Leaks Checks |  | 26d | 2014-08-04 | 2014-09-09 | 242242355 FS+13d | 293d | 0d | 8/5 M-F w/JLAB Holidays ReBaseline | MECH TECH [48 h] | 2,271.36 | 242242360 | IN | ELOUADRHIRI L | 1 | 1 | APP | H | LATIFA E |  | 12-007 |  | 12-054F | 13-002F | PE | 13-015 | PR | 14-001 |  |  |
| 242242380 | Sector 3 Windows Installation |  | 14d | 2014-08-27 | 2014-09-16 | 242242375 | 185d | 0d | 8/5 M-F w/JLAB Holidays ReBaseline | MECH TECH [40 h] | 1,892.8 | 242242380 | IN | ELOUADRHIRI L | 1 | 1 | APP | H | LATIFA E |  | 12-007 |  | 12-054F | 13-002F | PE | 13-015 | PR | 14-001 |  |  |
| 242242400 | Sector 4 Mirrors Alignment |  | 26d | 2014-09-23 | 2014-10-28 | 242242390, 242242380 FS+4d | 185d | 0d | 8/5 M-F w/JLAB Holidays ReBaseline | MECH TECH [80 h] | 3,785.6 | 242242400 | IN | ELOUADRHIRI L | 1 | 1 | APP | H | LATIFA E |  | 12-007 |  | 12-054F | 13-002F | PE | 13-015 | PR | 14-001 |  |  |
| 242242385 | Sector 3 Gas Leaks Checks |  | 22d | 2014-09-30 | 2014-10-29 | 242242380 FS+9d | 301d | 0d | 8/5 M-F w/JLAB Holidays ReBaseline | MECH TECH [40 h] | 1,892.8 | 242242385 | IN | ELOUADRHIRI L | 1 | 1 | APP | H | LATIFA E |  | 12-007 |  | 12-054F | 13-002F | PE | 13-015 | PR | 14-001 |  |  |
| 242242170 | Patch Panel Connectors Procurement |  | 77d | 2014-10-01 | 2015-01-30 | 9-155M | 192d | 7d | 8/5 M-F w/JLAB Holidays ReBaseline | SCIENTIST [28 h]; PROCUREMENT<$50K 60 | 14,647.58 | 242242170 | IN | ELOUADRHIRI L | 1 | 1 | APP | D | LATIFA E |  | 12-007 |  |  | 13-002F | PE | 13-015 | PR | 14-001 | 12-053 | PE |
| 242242185 | Procure Gas Line |  | 33d | 2014-10-01 | 2014-11-14 | 9-155M | 215d | 0d | 8/5 M-F w/JLAB Holidays ReBaseline | SCIENTIST [8 h]; PROCUREMENT<$50K 60 | 12,984.24 | 242242185 | IN | ELOUADRHIRI L | 1 | 1 | APP | D | LATIFA E |  | 12-007 |  |  | 13-002F | PE | 13-015 | PR | 14-001 |  | PE |
| 242242215 | Installation of FADC, DAQ, Computer, Electronics for 1 Sector |  | 42d | 2014-10-01 | 2014-12-01 | 9-155M | 227d | 42d | 8/5 M-F w/JLAB Holidays ReBaseline | SCIENTIST [8 h] | 601.44 | 242242215 | IN | ELOUADRHIRI L | 1 | 1 | APP | H | LATIFA E |  | 12-007 |  |  | 13-002F | PE | 13-015 | PR | 14-001 |  |  |
| 242242225 | Online Calibration Test |  | 24d | 2014-10-09 | 2014-11-11 | 242242222, 242242223 FS-24d, 242242220a, 242242220aa, 242242222a | 239d | 54d | 8/5 M-F w/JLAB Holidays ReBaseline | SCIENTIST [16 h] | 1,202.88 | 242242225 | IN | ELOUADRHIRI L | 1 | 1 | APP | H | LATIFA E |  | 12-007 |  |  | 13-002F | PE | 13-015 | PR | 14-001 |  |  |
| 242242405 | Sector 4 Windows Installation |  | 15d | 2014-10-29 | 2014-11-18 | 242242400 | 302d | 0d | 8/5 M-F w/JLAB Holidays ReBaseline | MECH TECH [40 h] | 1,892.8 | 242242405 | IN | ELOUADRHIRI L | 1 | 1 | APP | H | LATIFA E |  | 12-007 |  | 12-054F | 13-002F | PE | 13-015 | PR | 14-001 |  |  |
| 242242425 | Sector 5 Mirrors Alignment |  | 10d | 2014-10-29 | 2014-11-11 | 242242415, 242242400 | 185d | 0d | 8/5 M-F w/JLAB Holidays ReBaseline | MECH TECH [80 h] | 3,785.6 | 242242425 | IN | ELOUADRHIRI L | 1 | 1 | APP | H | LATIFA E |  | 12-007 |  | 12-054F | 13-002F | PE | 13-015 | PR | 14-001 |  |  |
| 242242190 | Install Gas Line (1S) |  | 10d | 2014-11-25 | 2014-12-10 | 242242185 FS+6d | 215d | 0d | 8/5 M-F w/JLAB Holidays ReBaseline | MECH TECH [20 h] | 946.4 | 242242190 | IN | ELOUADRHIRI L | 1 | 1 | APP | H | LATIFA E |  | 12-007 |  |  | 13-002F | PE | 13-015 | PR | 14-001 |  |  |
| 242242410 | Sector 4 Gas Leaks Checks |  | 13d | 2014-11-26 | 2014-12-16 | 242242405 FS+5d | 302d | 0d | 8/5 M-F w/JLAB Holidays ReBaseline | MECH TECH [40 h] | 1,892.8 | 242242410 | IN | ELOUADRHIRI L | 1 | 1 | APP | H | LATIFA E |  | 12-007 |  | 12-054F | 13-002F | PE | 13-015 | PR | 14-001 |  |  |
| 242242430 | Sector 5 Windows Installation |  | 13d | 2014-11-26 | 2014-12-16 | 242242425 FS+10d | 300d | 0d | 8/5 M-F w/JLAB Holidays ReBaseline | MECH TECH [40 h] | 1,892.8 | 242242430 | IN | ELOUADRHIRI L | 1 | 1 | APP | H | LATIFA E |  | 12-007 |  | 12-054F | 13-002F | PE | 13-015 | PR | 14-001 |  |  |
| 242242450 | Sector 6 Mirrors Alignment |  | 13d | 2014-11-26 | 2014-12-16 | 242242425 FS+10d, 242242440 FS-2d | 185d | 0d | 8/5 M-F w/JLAB Holidays ReBaseline | MECH TECH [80 h] | 3,785.6 | 242242450 | IN | ELOUADRHIRI L | 1 | 1 | APP | H | LATIFA E |  | 12-007 |  | 12-054F | 13-002F | PE | 13-015 | PR | 14-001 |  |  |
| 242242195 | Gas Line Quality Control |  | 5d | 2014-12-11 | 2014-12-17 | 242242190 | 215d | 30d | 8/5 M-F w/JLAB Holidays ReBaseline | MECH TECH [8 h] | 378.56 | 242242195 | IN | ELOUADRHIRI L | 1 | 1 | APP | H | LATIFA E |  | 12-007 |  |  | 13-002F | PE | 13-015 | PR | 14-001 |  |  |
| 242242435 | Sector 5 Gas Leaks Checks |  | 16d | 2014-12-17 | 2015-01-20 | 242242430 | 300d | 0d | 8/5 M-F w/JLAB Holidays ReBaseline | MECH TECH [40 h] | 1,892.8 | 242242435 | IN | ELOUADRHIRI L | 1 | 1 | APP | H | LATIFA E |  | 12-007 |  | 12-054F | 13-002F | PE | 13-015 | PR | 14-001 |  |  |
| 242242455 | Sector 6 Windows Installation |  | 16d | 2014-12-17 | 2015-01-20 | 242242450 | 185d | 0d | 8/5 M-F w/JLAB Holidays ReBaseline | MECH TECH [40 h] | 1,892.8 | 242242455 | IN | ELOUADRHIRI L | 1 | 1 | APP | H | LATIFA E |  | 12-007 |  | 12-054F | 13-002F | PE | 13-015 | PR | 14-001 |  |  |
| 242242460 | Sector 6 Gas Leaks Checks |  | 16d | 2015-01-20 | 2015-02-10 | 242242455 FS-1d | 185d | 0d | 8/5 M-F w/JLAB Holidays ReBaseline | MECH TECH [40 h] | 1,892.8 | 242242460 | IN | ELOUADRHIRI L | 1 | 1 | APP | H | LATIFA E |  | 12-007 |  | 12-054F | 13-002F | PE | 13-015 | PR | 14-001 |  |  |
| 242242500M | LTCC Complete | milestone | 0d | 2015-02-10 | 2015-02-10 | 242242036, 242242215, 242242335, 242242340, 242242460, 242242031, 242242161, 242242280, 242242330, 242242165b, 242242225, 242242169, 242242170, 242242295, 242242195, 242242107a, 242242295a, 242242077, 242242240, 242242030, 242242155, 242242205, 242242095a, 242242280a, 242242040, 242242270, 242242076, 242242090, 242242092, 242242095, 242242115, 242242036a, 242242164, 242242137, 242242107, 242242108, 242242031a | 185d | 0d | 8/5 M-F w/JLAB Holidays ReBaseline |  |  | 242242500M | IN | ELOUADRHIRI L | 1 | 1 | APP | M | LATIFA E |  | 12-007 | 12-027 | 12-054 | 13-002F |  | 13-015 | PR |  |  |  |

Notes:
- 242242270: Steps: Laser Mount on Box; Reference Mount on Box; Box rotation and reference check
- 242242415: Steps: Box Frame Support; Cut Line Mark; Box Cut; Wall Cut; Box Plates Fit; Patch Panel Fit; Rear Brace; Nose Installation; PMT, Mirrors Holes; Spine Refurbish; Mount PMT, Mirrors, WC
- 242242240: Steps: Nitrogen Fill 1/2"; Freon Fill; Snoop
- 242242440: Steps: Box Frame Support; Cut Line Mark; Box Cut; Wall Cut; Box Plates Fit; Patch Panel Fit; Rear Brace; Nose Installation; PMT, Mirrors Holes; Spine Refurbish; Mount PMT, Mirrors, WC
- 242242223: Steps: 1 Full sector HC connection; DAQ setup

| ID | WBS | Activity | Duration | Start | Finish | Predecessors | Total float | Free float | Calendar | Resources | Cost | PHAS - Project Phase | RESP - Responsibility | STRT%COMP for CM EVM | FNSH%COMP for CM EVM | CAM RESPONSIBLE | CR 12-007 | CR 12-027 | CR 13-002 | CR 12-054 | CR 11-026 | CR 08-016 | CR 09-012 | CR 13-014 | CR 12-040 | ReBaseline Actuals Adjustment | Original Activity ID Rebaseline | Over Under Fixed | EVMS Reporting Codes | BOE Procurement | CR 13-015 | Post Rebaseline | Obligated Prior to Rebaseline | CR 14-001 | BOE Labor |
| --- | --- | --- | --- | --- | --- | --- | --- | --- | --- | --- | --- | --- | --- | --- | --- | --- | --- | --- | --- | --- | --- | --- | --- | --- | --- | --- | --- | --- | --- | --- | --- | --- | --- | --- | --- |
|  | 3 | **1.4.2.3 COMPUTING** |  | 2010-10-01 | 2015-08-12 |  |  |  |  |  |  |  |  |  |  |  |  |  |  |  |  |  |  |  |  |  |  |  |  |  |  |  |  |  |  |
|  | 1 | **1.4.2.3.1 TRIGGER SYSTEM (Scintillators)** |  | 2011-12-01 | 2015-04-28 |  |  |  |  |  |  |  |  |  |  |  |  |  |  |  |  |  |  |  |  |  |  |  |  |  |  |  |  |  |  |
| 14231015 |  | SSP single board tests | 17d | 2011-12-01 | 2011-12-30 | 9-120M FS+41d | 183d | 0d |  | SCIENTIST [80 h] | 5,648.8 | IN | ELOUADRHIRI L | 1 | 1 | LATIFA E | 12-007 | 12-027F | 13-002F |  |  |  |  |  |  |  |  |  |  |  |  |  |  |  |  |
| 14231035 |  | GTP single board tests | 17d | 2011-12-01 | 2011-12-30 | 9-120M FS+41d | 209d | 189d |  | SCIENTIST [80 h] | 5,648.8 | IN | ELOUADRHIRI L | 1 | 1 | LATIFA E | 12-007 | 12-027F | 13-002F | 12-054F |  |  |  |  |  |  |  |  |  |  |  |  |  |  |  |
| 14231100 |  | TS single board tests | 17d | 2011-12-01 | 2011-12-30 | 9-120M FS+41d | 306d | 189d |  | SCIENTIST [80 h] | 5,648.8 | IN | ELOUADRHIRI L | 1 | 1 | LATIFA E | 12-007 |  | 13-002F |  |  |  |  |  |  |  |  |  |  |  |  |  |  |  |  |
| 14231005 |  | CTP Procurement Prep | 5d | 2012-01-03 | 2012-01-09 | 12223040M, 12223045, 9-120M FS+58d | 204d | 184d |  | SCIENTIST [40 h] | 2,824.4 |  | ELOUADRHIRI L | 1 | 1 | LATIFA E | 12-007 | 12-027F | 13-002F |  | 11-026 |  |  |  |  |  |  |  |  |  |  |  |  |  |  |
| 14231020 |  | SSP procurement prep | 6d | 2012-02-01 | 2012-02-08 | 14231015 FS+20d | 183d | 163d |  | SCIENTIST [40 h] | 2,824.4 | IN | ELOUADRHIRI L | 1 | 1 | LATIFA E | 12-007 | 12-027F | 13-002F |  |  |  |  |  |  |  |  |  |  |  |  |  |  |  |  |
| 14231055 |  | SD procurement prep | 6d | 2012-04-02 | 2012-04-09 | 9-120M FS+120d | 20d | 0d |  | SCIENTIST [40 h] | 2,824.4 | IN | ELOUADRHIRI L | 1 | 1 | LATIFA E | 12-007 |  | 13-002F |  |  |  |  |  |  |  |  |  |  |  |  |  |  |  |  |
| 14231060 |  | SD procurement (24 boards) | 180d | 2012-04-10 | 2012-12-31 | 14231055 | 20d | 0d |  | PROCUREMENT<$50K 60 NO ESCALATION FY13 | 18,240 | IN | ELOUADRHIRI L | 1 | 1 | LATIFA E | 12-007 |  | 13-002F |  |  |  |  |  |  |  |  |  |  |  |  |  |  |  |  |
| 14231070 |  | TI procurement prep | 6d | 2012-05-01 | 2012-05-08 | 9-120M FS+141d | 20d | 0d |  | SCIENTIST [40 h] | 2,824.4 | IN | ELOUADRHIRI L | 1 | 1 | LATIFA E | 12-007 |  | 13-002F |  |  |  |  |  |  |  |  |  |  |  |  |  |  |  |  |
| 14231075 |  | TI procurement (52 boards) | 159d | 2012-05-09 | 2012-12-31 | 14231070 | 20d | 0d |  | PROCUREMENT<$50K 60 NO ESCALATION FY13; PROCUREMENT>$50K 69 NO ESCALATION FY13 | 109,980 | IN | ELOUADRHIRI L | 1 | 1 | LATIFA E | 12-007 |  | 13-002F |  |  |  |  |  |  |  |  |  |  |  |  |  |  |  |  |
| 14231085 |  | TD procurement prep | 6d | 2012-06-01 | 2012-06-11 | 9-120M FS+163d | 20d | 0d |  | SCIENTIST [40 h] | 2,824.4 | IN | ELOUADRHIRI L | 1 | 1 | LATIFA E | 12-007 |  | 13-002F |  |  |  |  |  |  |  |  |  |  |  |  |  |  |  |  |
| 14231090 |  | TD procurement (10 boards) | 137d | 2012-06-12 | 2012-12-31 | 14231085 | 20d | 0d |  | PROCUREMENT<$50K 60 NO ESCALATION FY13; PROCUREMENT>$50K 69 NO ESCALATION FY13 | 58,150 | IN | ELOUADRHIRI L | 1 | 1 | LATIFA E | 12-007 |  | 13-002F |  |  |  |  |  |  |  |  |  |  |  |  |  |  |  |  |
| 14231007 |  | CTP procurement (22 boards) | 99d | 2012-10-01 | 2013-02-28 | 14231005, 9-130M | 20d | 0d |  | PROCUREMENT<$50K 60; PROCUREMENT>$50K 69 | 140,410.63 |  | ELOUADRHIRI L | 1 | 1 | LATIFA E | 12-007 | 12-027 | 13-002F |  | 11-026 | 08-016 | 09-012 |  |  |  |  |  |  |  |  |  |  |  |  |
| 14231025 |  | SSP procurement (15 boards) | 130d | 2012-10-01 | 2013-04-12 | 14231020, 9-130M | 20d | 0d |  | PROCUREMENT<$50K 60; PROCUREMENT>$50K 69 | 134,662.95 | IN | ELOUADRHIRI L | 1 | 1 | LATIFA E | 12-007 | 12-027 | 13-002F |  |  |  |  |  |  |  |  |  |  |  |  |  |  |  |  |
| 14231040 |  | GTP procurement prep | 46d | 2012-11-28 | 2013-02-08 | 9-130M FS+40d, 14231035 FS+40d | 20d | 0d |  | SCIENTIST [40 h] | 2,914.4 | IN | ELOUADRHIRI L | 1 | 1 | LATIFA E | 12-007 | 12-027 | 13-002F | 12-054 |  |  |  |  |  |  |  |  |  |  |  |  |  |  |  |
| 14231065 |  | SD testing of 24 boards | 169d | 2013-01-02 | 2013-08-30 | 14231060 | 20d |  |  | SCIENTIST [54.52 h] | 3,972.33 | IN | ELOUADRHIRI L | 1 | 1 | LATIFA E | 12-007 |  | 13-002F |  |  |  |  | 13-014 |  |  |  |  |  |  |  |  |  |  |  |
| 14231045 |  | GTP procurement (2 boards) | 93d | 2013-02-11 | 2013-06-21 | 9-130M, 14231040 | 20d | 0d |  | PROCUREMENT<$50K 60 | 13,414.7 | IN | ELOUADRHIRI L | 1 | 1 | LATIFA E | 12-007 | 12-027 | 13-002F | 12-054 |  |  |  |  |  |  |  |  |  |  |  |  |  |  |  |
| 14231105 |  | TS procurement prep | 6d | 2013-04-08 | 2013-04-15 | 9-130M FS+125d, 14231100 FS+125d | 117d |  |  | SCIENTIST [40 h] | 2,914.4 | IN | ELOUADRHIRI L | 1 | 1 | LATIFA E | 12-007 | 12-027 | 13-002F | 12-054 |  |  |  |  |  |  |  |  |  |  |  |  |  |  |  |
| 14231030 |  | SSP testing of 15 boards (Future Activity Complete prior to Rebaseline) | 1d | 2013-08-30 | 2013-08-30 | 9-130M FS+227d | 20d |  |  | SCIENTIST |  | IN | ELOUADRHIRI L | 1 | 1 | LATIFA E | 12-007 | 12-027 | 13-002F |  |  |  |  | 13-014 | 12-040 |  |  |  |  |  |  |  |  |  |  |
| 14231095 |  | TD testing of 10 boards (Future Activity Complete prior to Rebaseline) | 1d | 2013-08-30 | 2013-08-30 | 9-130M FS+227d | 20d |  |  | SCIENTIST |  | IN | ELOUADRHIRI L | 1 | 1 | LATIFA E | 12-007 |  | 13-002F |  |  |  |  | 13-014 | 12-040 |  |  |  |  |  |  |  |  |  |  |
| 14231125 |  | Re-Baseline Actuals Adjustment | 1d | 2013-08-30 | 2013-08-30 | 9-130M FS+227d | 20d |  |  | PROCUREMENT>$50K 69 NO ESCALATION | -99,220.55 |  | ELOUADRHIRI L | 1 | 1 | LATIFA E |  |  |  |  |  |  |  | 13-014 |  | ADJ |  |  |  |  |  |  |  |  |  |
| 24231000 |  | AVAGO QSFP OPTIC TRANS | 43d | 2013-09-03 | 2013-10-31 | 9-130M FS+228d | 528d | 525d | 8/5 M-F w/JLAB Holidays ReBaseline | PROCUREMENT<$50K 60 NO ESCALATION FY14 | 1,017.93 |  | ELOUADRHIRI L | 1 | 1 | LATIFA E | 12-007 | 12-027 | 13-002F |  | 11-026 | 08-016 | 09-012 |  |  |  | 24231007 | y | U | PE | 13-015 | PR | OB |  |  |
| 24231045 |  | GTP procurement (2 boards) | 78d | 2013-10-01 | 2014-01-31 | 9-140M | 351d | 0d | 8/5 M-F w/JLAB Holidays ReBaseline | PROCUREMENT<$50K 60 | 14,446.6 | IN | ELOUADRHIRI L | 1 | 1 | LATIFA E | 12-007 | 12-027 | 13-002F | 12-054 |  |  |  |  |  |  | 24231045 |  | U | PE | 13-015 | PR |  | 14-001 |  |
| 24231005 |  | CTP procurement Prep | 20d | 2014-10-01 | 2014-10-28 | 9-155M | 41d | 0d | 8/5 M-F w/JLAB Holidays ReBaseline | ELEC ENG [80 h] | 6,010.4 |  | ELOUADRHIRI L | 1 | 1 | LATIFA E | 12-007 | 12-027 | 13-002F |  | 11-026 | 08-016 | 09-012 |  |  |  | 24231005 |  | H |  | 13-015 | PR |  | 14-001 | PE |
| 24231007 |  | CTP procurement (22 boards) | 119d | 2014-10-29 | 2015-04-28 | 24231005 | 41d | 0d | 8/5 M-F w/JLAB Holidays ReBaseline | PROCUREMENT<$50K 60; PROCUREMENT>$50K 69 | 158,912.6 |  | ELOUADRHIRI L | 1 | 1 | LATIFA E | 12-007 | 12-027 | 13-002F |  | 11-026 | 08-016 | 09-012 |  |  |  | 24231007 |  | U | PE | 13-015 | PR |  | 14-001 |  |

| ID | WBS | Activity | Type | Duration | Start | Finish | Predecessors | Total float | Free float | Calendar | Resources | Cost | RESP - Responsibility | STRT%COMP for CM EVM | FNSH%COMP for CM EVM | CAM RESPONSIBLE | CR 11-026 | CR 12-007 | CR 13-002 | CR 13-014 | ReBaseline Actuals Adjustment | Original Activity ID Rebaseline | PHAS - Project Phase | EVMS Reporting Codes | CR 12-027 | CR 12-054 | BOE Procurement | CR 13-015 | Post Rebaseline | CR 14-001 | CR 08-016 | Activities with Steps | CR 09-012 | CR 09-030 Repair | BOE Labor |
| --- | --- | --- | --- | --- | --- | --- | --- | --- | --- | --- | --- | --- | --- | --- | --- | --- | --- | --- | --- | --- | --- | --- | --- | --- | --- | --- | --- | --- | --- | --- | --- | --- | --- | --- | --- |
|  | 2 | **1.4.2.3.2 DAQ** |  |  | 2012-01-03 | 2015-08-12 |  |  |  |  |  |  |  |  |  |  |  |  |  |  |  |  |  |  |  |  |  |  |  |  |  |  |  |  |  |
| 14232010 |  | CLAS12 DAQ/online software updates FY12 |  | 189d | 2012-01-03 | 2012-09-28 | 9-120M FS+58d | 20d | 0d |  | SCIENTIST [533.47 h]; PD UNIV STUDNT [1066.94 h]; VISTNG USERS [533.47 h] | 59,364.55 | ELOUADRHIRI L | 1 | 1 | LATIFA E | 11-026 | 12-007 | 13-002F |  |  |  |  |  |  |  |  |  |  |  |  |  |  |  |  |
| 14232030 |  | Re-Baseline Actuals Adjustment |  | 1d | 2013-08-30 | 2013-08-30 | 9-130M FS+227d | 20d |  |  | PROCUREMENT>$50K 69 NO ESCALATION | -43,873.11 | ELOUADRHIRI L | 1 | 1 | LATIFA E |  |  |  | 13-014 | ADJ |  |  |  |  |  |  |  |  |  |  |  |  |  |  |
| 24232022 |  | Procure GE VME controllers (53) |  | 126d | 2014-10-01 | 2015-04-09 | 9-155M | 92d | 0d | 8/5 M-F w/JLAB Holidays ReBaseline | PROCUREMENT>$50K 69; PROCUREMENT<$50K 60 | 218,762.8 | ELOUADRHIRI L | 1 | 1 | LATIFA E |  | 12-007 | 13-002F |  |  | 24232022 | IN | U | 12-027 | 12-054 | EV | 13-015 | PR | 14-001 |  |  |  |  |  |
| 24232025 |  | Install GE VME controllers (22) |  | 86d | 2015-04-10 | 2015-08-12 | 24232022 | 92d | 89d | 8/5 M-F w/JLAB Holidays ReBaseline | SCIENTIST [320 h] | 24,057.6 | ELOUADRHIRI L | 1 | 1 | LATIFA E | 11-026 | 12-007 | 13-002F |  |  | 24232025 | IN | S | 12-027 | 12-054 |  | 13-015 | PR | 14-001 | 08-016 | ST | 09-012 | 09-030 | PE |
|  | 3 | **1.4.2.3.3 ONLINE COMPUTING** |  |  | 2011-10-03 | 2015-07-23 |  |  |  |  |  |  |  |  |  |  |  |  |  |  |  |  |  |  |  |  |  |  |  |  |  |  |  |  |  |
| 14233005 |  | ONLINE COMP-P-#1 Contsruction Setup Historical Contributed Labor |  | 21d | 2011-10-03 | 2011-10-31 | 9-120M | 474d |  |  | CONTRB UNIV LBR [13.71 h] |  | ELOUADRHIRI L | 1 | 1 | LATIFA E | 11-026 | 12-007 | 13-002F |  |  |  |  |  |  |  |  |  |  |  |  |  | 09-012 |  |  |
| 14233007 |  | CLAS12 Online and Monitoring software updates |  | 186d | 2012-01-06 | 2012-09-28 | 9-120M FS+61d | 248d |  |  | SCIENTIST [1120 h] | 79,083.2 | ELOUADRHIRI L | 1 | 1 | LATIFA E |  | 12-007 | 13-002F |  |  |  | IN |  |  |  |  |  |  |  |  |  |  |  |  |
| 14233075 |  | Re-Baseline Actuals Adjustment |  | 1d | 2013-08-30 | 2013-08-30 | 9-130M FS+227d | 20d |  |  | PROCUREMENT>$50K 69 NO ESCALATION | -75,132.85 | ELOUADRHIRI L | 1 | 1 | LATIFA E |  |  |  | 13-014 | ADJ |  |  |  |  |  |  |  |  |  |  |  |  |  |  |
| 24233010 |  | Ethernet wiring inside Hall B (10Gbit) |  | 78d | 2015-01-07 | 2015-04-27 | 9-155M FS+60d | 166d | 60d | 8/5 M-F w/JLAB Holidays ReBaseline | PROCUREMENT<$50K 60 | 43,339.8 | ELOUADRHIRI L | 1 | 1 | LATIFA E | 11-026 | 12-007 | 13-002F |  |  | 24233010 |  | D |  | 12-054 | EV | 13-015 | PR | 14-001 |  |  | 09-012 |  |  |
| 24233015 |  | Trigger system fibers wiring |  | 78d | 2015-01-07 | 2015-04-27 | 9-155M FS+60d | 166d | 60d | 8/5 M-F w/JLAB Holidays ReBaseline | PROCUREMENT<$50K 60 | 54,690.7 | ELOUADRHIRI L | 1 | 1 | LATIFA E | 11-026 | 12-007 | 13-002F |  |  | 24233015 | IN | D |  | 12-054 | EV | 13-015 | PR | 14-001 |  |  |  |  |  |
| 24233020 |  | Procure CISCO 2960S switches (24 Cu ports) (15) |  | 78d | 2015-01-07 | 2015-04-27 | 9-155M FS+60d | 125d | 0d | 8/5 M-F w/JLAB Holidays ReBaseline | PROCUREMENT<$50K 60; PROCUREMENT>$50K 69 | 68,105.4 | ELOUADRHIRI L | 1 | 1 | LATIFA E |  | 12-007 | 13-002F |  |  | 24233020 | IN | U |  | 12-054 | PE | 13-015 | PR | 14-001 |  |  |  |  |  |
| 24233030 |  | Procure 4-port 10GBit Blades for BigIron |  | 78d | 2015-01-07 | 2015-04-27 | 9-155M FS+60d | 146d | 0d | 8/5 M-F w/JLAB Holidays ReBaseline | PROCUREMENT<$50K 60; PROCUREMENT>$50K 69 | 51,595 | ELOUADRHIRI L | 1 | 1 | LATIFA E |  | 12-007 | 13-002F |  |  | 24233030 | IN | U |  | 12-054 | PE | 13-015 | PR | 14-001 |  |  |  |  |  |
| 24233040 |  | Procure Ethernet fibers/Cu wires |  | 78d | 2015-01-07 | 2015-04-27 | 9-155M FS+60d | 125d | 0d | 8/5 M-F w/JLAB Holidays ReBaseline | PROCUREMENT<$50K 60 | 21,669.9 | ELOUADRHIRI L | 1 | 1 | LATIFA E |  | 12-007 | 13-002F |  |  | 24233040 | IN | D |  | 12-054 | CP | 13-015 | PR | 14-001 |  |  |  |  |  |
| 24233050 |  | Procure Terminal servers (Etherlite32) (10) |  | 78d | 2015-01-07 | 2015-04-27 | 9-155M FS+60d | 125d | 0d | 8/5 M-F w/JLAB Holidays ReBaseline | PROCUREMENT<$50K 60 | 15,478.5 | ELOUADRHIRI L | 1 | 1 | LATIFA E |  | 12-007 | 13-002F |  |  | 24233050 | IN | U |  | 12-054 | CP | 13-015 | PR | 14-001 |  |  |  |  |  |
| 24233060 |  | Procure daq/online computers |  | 98d | 2015-01-07 | 2015-05-26 | 9-155M FS+60d | 106d | 0d | 8/5 M-F w/JLAB Holidays ReBaseline | PROCUREMENT>$50K 69; PROCUREMENT<$50K 60 | 85,647.7 | ELOUADRHIRI L | 1 | 1 | LATIFA E |  | 12-007 | 13-002F |  |  | 24233060 | IN | D |  | 12-054 | CP | 13-015 | PR | 14-001 |  |  |  |  |  |
| 24233025 |  | Install CISCO 2960S switches (24 Cu ports) (15) |  | 41d | 2015-04-28 | 2015-06-25 | 24233020 | 125d | 19d | 8/5 M-F w/JLAB Holidays ReBaseline | SCIENTIST [160 h] | 12,028.8 | ELOUADRHIRI L | 1 | 1 | LATIFA E |  | 12-007 | 13-002F |  |  | 24233025 | IN | S |  | 12-054 |  | 13-015 | PR | 14-001 |  | ST |  |  | PE |
| 24233035 |  | Install 4-port 10GBit Blades for BigIron |  | 20d | 2015-04-28 | 2015-05-26 | 24233030 | 146d | 40d | 8/5 M-F w/JLAB Holidays ReBaseline | SCIENTIST [40 h] | 3,007.2 | ELOUADRHIRI L | 1 | 1 | LATIFA E |  | 12-007 | 13-002F |  |  | 24233035 | IN | H |  | 12-054 |  | 13-015 | PR | 14-001 |  |  |  |  | PE |
| 24233045 |  | Install Ethernet fibers/Cu wires |  | 41d | 2015-04-28 | 2015-06-25 | 24233040 | 125d | 19d | 8/5 M-F w/JLAB Holidays ReBaseline | SCIENTIST [80 h] | 6,014.4 | ELOUADRHIRI L | 1 | 1 | LATIFA E |  | 12-007 | 13-002F |  |  | 24233045 | IN | H |  | 12-054 |  | 13-015 | PR | 14-001 |  |  |  |  | PE |
| 24233055 |  | Install Terminal servers (Etherlite32) (10) |  | 41d | 2015-04-28 | 2015-06-25 | 24233050 | 125d | 19d | 8/5 M-F w/JLAB Holidays ReBaseline | SCIENTIST [40 h] | 3,007.2 | ELOUADRHIRI L | 1 | 1 | LATIFA E |  | 12-007 | 13-002F |  |  | 24233055 | IN | H |  | 12-054 |  | 13-015 | PR | 14-001 |  |  |  |  | PE |
| 24233065 |  | Install daq/online computers |  | 40d | 2015-05-27 | 2015-07-23 | 24233060 | 106d | 0d | 8/5 M-F w/JLAB Holidays ReBaseline | SCIENTIST [280 h] | 21,050.4 | ELOUADRHIRI L | 1 | 1 | LATIFA E |  | 12-007 | 13-002F |  |  | 24233065 | IN | S |  | 12-054 |  | 13-015 | PR | 14-001 |  | ST |  |  | PE |
| 24233070M |  | Online computing infrastructure complete | milestone | 0d | 2015-07-23 | 2015-07-23 | 24233065, 24233025, 24233015, 24233010, 24233035, 24233045, 24233055 | 106d | 103d | 8/5 M-F w/JLAB Holidays ReBaseline |  |  | ELOUADRHIRI L | 1 | 1 | LATIFA E |  | 12-007 | 13-002F |  |  | 24233070M | IN | M |  | 12-054 |  | 13-015 | PR |  |  |  |  |  |  |
|  | 4 | **1.4.2.3.4 OFFLINE COMPUTING** |  |  | 2011-10-03 | 2013-08-30 |  |  |  |  |  |  |  |  |  |  |  |  |  |  |  |  |  |  |  |  |  |  |  |  |  |  |  |  |  |
| 14234005 |  | OFFLINE COMP- Constrctn Setup (P-#1) Historical |  | 21d | 2011-10-03 | 2011-10-31 | 9-120M | 1027d | 1024d |  | SCIENTIST [13.71 h]; COMP SCIENT [13.71 h]; CONTRB UNIV LBR [287.99 h]; VISTNG USERS [89.14 h] | 3,591.33 | ELOUADRHIRI L | 1 | 1 | LATIFA E | 11-026 | 12-007 | 13-002F |  |  |  |  |  |  |  |  |  |  |  |  |  |  |  |  |
| 14234020LOE |  | Contributed Labor Effort |  | 434d | 2011-12-01 | 2013-08-30 | 9-120M FS+41d | 640d | 600d |  | CONTRB UNIV LBR [6429.67 h] |  | ELOUADRHIRI L | 1 | 1 | LATIFA E | 11-026 | 12-007 | 13-002F | 13-014 |  |  |  |  |  |  |  |  |  |  |  |  |  |  |  |
| 14234025 |  | Re-Baseline Actuals Adjustment |  | 1d | 2013-08-30 | 2013-08-30 | 9-130M FS+227d | 20d |  |  | PROCUREMENT>$50K 69 NO ESCALATION | -3,591.33 | ELOUADRHIRI L | 1 | 1 | LATIFA E |  |  |  | 13-014 | ADJ |  |  |  |  |  |  |  |  |  |  |  |  |  |  |

Notes:
- 24232025: Steps: Install in crates and wire up; Register IP names, determine test software to be used; Boot one by one and run test software; send to repair if needed
- 24233025: Steps: Install CISCO switches in racks and wire up; Configure all switches for corresponding subnets
- 24233065: Steps: Install daq/online computers hardware and wire up; Install operating systems and daq/online software; Test entire system

| ID | WBS | Activity | Type | Duration | Start | Finish | Predecessors | Total float | Free float | Calendar | Resources | Cost | RESP - Responsibility | STRT%COMP for CM EVM | FNSH%COMP for CM EVM | CAM RESPONSIBLE | CR 11-026 | CR 13-002 | CR 12-001 | PHAS - Project Phase | CR 08-016 | CR 09-012 | CR 13-014 | ReBaseline Actuals Adjustment | Original Activity ID Rebaseline | EVMS Reporting Codes | BOE Procurement | CR 13-015 | Post Rebaseline | CR 14-001 | Activities with Steps | BOE Labor | CR 08-052 | CR 11-035 | CR 12-007 | CR 12-014 | CR 12-047 | Advance Purchase Plan > 500K | CR 08-045 | 12 GEV MAJOR PROCUREMENT CATAGORY | CR 12-016 | CR 12-054 | CR 12-027 | CR 12-053 | Pre Rebaseline Remaining Budget | BOE Expenses | Previously In Progress |
| --- | --- | --- | --- | --- | --- | --- | --- | --- | --- | --- | --- | --- | --- | --- | --- | --- | --- | --- | --- | --- | --- | --- | --- | --- | --- | --- | --- | --- | --- | --- | --- | --- | --- | --- | --- | --- | --- | --- | --- | --- | --- | --- | --- | --- | --- | --- | --- |
|  | 5 | **1.4.2.3.5 SLOW CONTROLS** |  |  | 2010-10-01 | 2015-03-19 |  |  |  |  |  |  |  |  |  |  |  |  |  |  |  |  |  |  |  |  |  |  |  |  |  |  |  |  |  |  |  |  |  |  |  |  |  |  |  |  |  |
| 14235005 |  | SLOW CNTL- Constrctn Setup (P-#1) |  | 245d | 2010-10-01 | 2011-09-27 | 12223045, 9-110M | 573d | 0d |  | SCIENTIST [560 h]; VISTNG USERS [1040 h] | 57,800 | ELOUADRHIRI L | 1 | 1 | LATIFA E | 11-026 | 13-002F |  |  |  |  |  |  |  |  |  |  |  |  |  |  |  |  |  |  |  |  |  |  |  |  |  |  |  |  |  |
| 14235010 |  | SLOW CNTL- Constrctn Setup (P-#2) FY11 |  | 3d | 2011-09-28 | 2011-09-30 | 14235005 | 573d | 0d |  | SCIENTIST [7.84 h]; VISTNG USERS [15.18 h] | 820.81 | ELOUADRHIRI L | 1 | 1 | LATIFA E | 11-026 | 13-002F | 12-001 |  |  |  |  |  |  |  |  |  |  |  |  |  |  |  |  |  |  |  |  |  |  |  |  |  |  |  |  |
| 14235010a |  | SLOW CNTL- Constrctn Setup (P-#2) FY12 |  | 247d | 2011-10-03 | 2012-09-28 | 14235005, 14235010 | 573d | 0d |  | VISTNG USERS [1224.82 h]; SCIENTIST [632.16 h] | 68,312.59 | ELOUADRHIRI L | 1 | 1 | LATIFA E | 11-026 | 13-002F | 12-001 |  |  |  |  |  |  |  |  |  |  |  |  |  |  |  |  |  |  |  |  |  |  |  |  |  |  |  |  |
| 14235015 |  | SLOW CNTL- Constrctn Setup (P-#3) |  | 228d | 2012-10-01 | 2013-08-30 | 14235010, 14235010a | 573d | 570d |  | VISTNG USERS [1153.96 h]; PROCUREMENT<$50K 60; SCIENTIST [558.37 h] | 63,704.26 | ELOUADRHIRI L | 1 | 1 | LATIFA E | 11-026 | 13-002F | 12-001 | IN | 08-016 | 09-012 | 13-014 |  |  |  |  |  |  |  |  |  |  |  |  |  |  |  |  |  |  |  |  |  |  |  |  |
| 14235020 |  | Re-Baseline Actuals Adjustment |  | 1d | 2013-08-30 | 2013-08-30 | 9-130M FS+227d | 20d |  |  | PROCUREMENT>$50K 69 NO ESCALATION | -133,300.56 | ELOUADRHIRI L | 1 | 1 | LATIFA E |  |  |  |  |  |  | 13-014 | ADJ |  |  |  |  |  |  |  |  |  |  |  |  |  |  |  |  |  |  |  |  |  |  |  |
| 24235005 |  | SLOW CNTL (EPICS software development) |  | 20d | 2013-10-01 | 2013-10-28 | 9-140M | 232d | 39d | 8/5 M-F w/JLAB Holidays ReBaseline | PROCUREMENT<$50K 60 | 9,390.29 | ELOUADRHIRI L | 1 | 1 | LATIFA E | 11-026 | 13-002F | 12-001 |  |  |  |  |  | 24235005 | D | OB | 13-015 | PR | 14-001 |  |  |  |  |  |  |  |  |  |  |  |  |  |  |  |  |  |
| 24235010a |  | SLOW CNTL (EPICS device drivers development) |  | 189d | 2014-01-06 | 2014-10-01 | 24235005, 9-140M FS+59d | 193d | 0d | 8/5 M-F w/JLAB Holidays ReBaseline | SCIENTIST [880 h] | 66,158.4 | ELOUADRHIRI L | 1 | 1 | LATIFA E | 11-026 | 13-002F | 12-001 |  |  |  |  |  | 24235010a | S |  | 13-015 | PR | 14-001 | ST | PE |  |  |  |  |  |  |  |  |  |  |  |  |  |  |  |
| 24235015 |  | SLOW CNTL (EPICS software development) |  | 110d | 2014-10-02 | 2015-03-19 | 24235010a | 193d | 190d | 8/5 M-F w/JLAB Holidays ReBaseline | SCIENTIST [880 h]; VISTNG USERS [3520 h] | 138,635.2 | ELOUADRHIRI L | 1 | 1 | LATIFA E | 11-026 | 13-002F | 12-001 | IN | 08-016 | 09-012 |  |  | 24235015 | S |  | 13-015 | PR | 14-001 | ST | PE |  |  |  |  |  |  |  |  |  |  |  |  |  |  |  |
|  | 4 | **1.4.2.4 ELECTRONICS** |  |  | 2010-09-30 | 2015-10-01 |  |  |  |  |  |  |  |  |  |  |  |  |  |  |  |  |  |  |  |  |  |  |  |  |  |  |  |  |  |  |  |  |  |  |  |  |  |  |  |  |  |
|  | 1 | **1.4.2.4.1 ADC** |  |  | 2011-10-03 | 2013-08-30 |  |  |  |  |  |  |  |  |  |  |  |  |  |  |  |  |  |  |  |  |  |  |  |  |  |  |  |  |  |  |  |  |  |  |  |  |  |  |  |  |  |
| 14241005 |  | ADC Prcrmnt |  | 20d | 2011-10-03 | 2011-10-28 | 9-120M, 12224005 | 699d | 18d |  | SCIENTIST [40 h]; ELEC TECH [160 h] | 9,885.2 | ELOUADRHIRI L | 1 | 1 | LATIFA E |  | 13-002F |  |  |  |  |  |  |  |  |  |  |  |  |  |  | 08-052 | 11 -035 | 12-007 | 12-014 | 12-047F |  |  |  |  |  |  |  |  |  |  |
| 14241010 |  | FADC-250 (275) procurement |  | 231d | 2012-01-04 | 2012-11-30 | 9-120M FS+59d, 14241005 FS+21d | 681d | 0d |  | PROCUREMENT<$50K 60 NO ESCALATION; PROCUREMENT>$50K 69 NO ESCALATION | 1,136,336.85 | ELOUADRHIRI L | 1 | 1 | LATIFA E |  | 13-002F |  | IN |  |  |  |  |  |  |  |  |  |  |  |  |  | 11 -035 | 12-007 | 12-014 | 12-047F | APP | 08-045 | 4241 |  |  |  |  |  |  |  |
| 14241015 |  | UMASS - FADC-250 testing (275) |  | 98d | 2012-10-31 | 2013-03-29 | 12224005, 14241010 FS-21d | 681d | 678d |  | PROCUREMENT<$50K 60 | 3,523.32 | ELOUADRHIRI L | 1 | 1 | LATIFA E |  | 13-002F |  |  |  |  |  |  |  |  |  |  |  |  |  |  | 08-052 | 11 -035 | 12-007 | 12-014 | 12-047 |  |  |  |  |  |  |  |  |  |  |
| 14241020 |  | Re-Baseline Actuals Adjustment |  | 1d | 2013-08-30 | 2013-08-30 | 9-130M FS+227d | 20d |  |  | PROCUREMENT>$50K 69 NO ESCALATION | 42,472.21 | ELOUADRHIRI L | 1 | 1 | LATIFA E |  |  |  |  |  |  | 13-014 | ADJ |  |  |  |  |  |  |  |  |  |  |  |  |  |  |  |  |  |  |  |  |  |  |  |
|  | 2 | **1.4.2.4.2 TDC AND DISCRIMINATORS** |  |  | 2012-01-04 | 2015-10-01 |  |  |  |  |  |  |  |  |  |  |  |  |  |  |  |  |  |  |  |  |  |  |  |  |  |  |  |  |  |  |  |  |  |  |  |  |  |  |  |  |  |
| 14242033 |  | JLab Discriminator First Article and Non-Recurring Engineering |  | 104d | 2012-01-04 | 2012-05-31 | 9-120M FS+59d | 641d | 0d |  | PROCUREMENT<$50K 60 NO ESCALATION; PROCUREMENT>$50K 69 NO ESCALATION | 26,137.5 | ELOUADRHIRI L | 1 | 1 | LATIFA E |  | 13-002F |  | IN |  |  |  |  |  |  |  |  |  |  |  |  |  |  |  |  |  | APP |  | 4242 | 12-016 | 12-054F |  |  |  |  |  |
| 14242035 |  | JLab Discriminator (275) procurement |  | 169d | 2012-01-04 | 2012-08-31 | 14242033 FS-104d, 9-120M FS+59d | 641d | 0d |  | PROCUREMENT<$50K 60 NO ESCALATION; PROCUREMENT>$50K 69 NO ESCALATION | 390,403 | ELOUADRHIRI L | 1 | 1 | LATIFA E |  | 13-002F |  | IN |  |  |  |  |  |  |  |  |  |  |  |  |  |  | 12-007 |  |  | APP |  | 4242 | 12-016 | 12-054F |  |  |  |  |  |
| 14242005 |  | CAEN v1190 TDCs (reuse) (31) installation |  | 42d | 2012-06-01 | 2012-07-31 | 12224005, 9-120M FS+163d | 843d | 228d |  | SCIENTIST [8 h] | 564.88 | ELOUADRHIRI L | 1 | 1 | LATIFA E | 11-026 | 13-002F |  |  |  |  |  |  |  |  |  |  |  |  |  |  |  |  | 12-007 |  |  |  |  |  |  |  |  |  |  |  |  |
| 14242010 |  | CAEN v1290 TDCs (reuse) (24) installation |  | 42d | 2012-06-01 | 2012-07-31 | 9-120M FS+163d | 843d | 228d |  | SCIENTIST [8 h] | 564.88 | ELOUADRHIRI L | 1 | 1 | LATIFA E | 11-026 | 13-002F |  | IN |  |  |  |  |  |  |  |  |  |  |  |  |  |  | 12-007 |  |  | APP | 08-045 | 4242 |  |  |  |  |  |  |  |
| 14242015 |  | CAEN v1290N TDCs (reuse) (7) installation |  | 42d | 2012-06-01 | 2012-07-31 | 9-120M FS+163d | 843d | 228d |  | SCIENTIST [8 h] | 564.88 | ELOUADRHIRI L | 1 | 1 | LATIFA E |  | 13-002F |  | IN |  |  |  |  |  |  |  |  |  |  |  |  |  |  | 12-007 |  |  | APP |  | 4242 |  |  |  |  |  |  |  |
| 14242020 |  | JLab TDC Fanout procurement prep |  | 7d | 2012-10-01 | 2012-10-09 | 9-130M | 615d | 0d |  | SCIENTIST [40 h] | 2,914.4 | ELOUADRHIRI L | 1 | 1 | LATIFA E |  | 13-002F |  | IN |  |  |  |  |  |  |  |  |  |  |  |  |  |  | 12-007 |  |  | APP |  | 4242 |  |  | 12-027 |  |  |  |  |
| 14242045 |  | ORTEC 935F discr. procurement prep |  | 7d | 2012-10-01 | 2012-10-09 | 9-130M | 615d | 0d |  | SCIENTIST [40 h] | 2,914.4 | ELOUADRHIRI L | 1 | 1 | LATIFA E |  | 13-002F |  | IN |  |  |  |  |  |  |  |  |  |  |  |  |  |  | 12-007 |  |  | APP |  | 4242 |  |  | 12-027 |  |  |  |  |
| 14242025 |  | JLab TDC Fanout (25) procurement |  | 120d | 2012-10-10 | 2013-04-09 | 14242020 | 615d | 0d |  | PROCUREMENT<$50K 60; PROCUREMENT>$50K 69 | 51,595 | ELOUADRHIRI L | 1 | 1 | LATIFA E |  | 13-002F |  | IN |  |  |  |  |  |  |  |  |  |  |  |  |  |  | 12-007 |  |  | APP |  | 4242 |  |  | 12-027 |  |  |  |  |
| 14242050 |  | ORTEC 935F discr. (25) procurement |  | 120d | 2012-10-10 | 2013-04-09 | 14242045 | 615d | 0d |  | PROCUREMENT<$50K 60; PROCUREMENT>$50K 69 | 87,814.69 | ELOUADRHIRI L | 1 | 1 | LATIFA E |  | 13-002F |  | IN |  |  |  |  |  |  |  |  |  |  |  |  |  |  | 12-007 |  |  | APP |  | 4242 |  |  | 12-027 |  |  |  |  |
| 14242040 |  | JLab Discriminator (275) test/install |  | 59d | 2013-03-05 | 2013-05-24 | 14242035 FS+120d | 641d | 26d |  | PD UNIV STUDNT [320 h] | 3,523.2 | ELOUADRHIRI L | 1 | 1 | LATIFA E |  | 13-002F |  | IN |  |  |  |  |  |  |  |  |  |  |  |  |  |  | 12-007 |  |  | APP |  | 4242 | 12-016 | 12-054 |  | 12-053 |  |  |  |
| 14242030 |  | JLab TDC Fanout (25) test/install |  | 59d | 2013-04-10 | 2013-07-02 | 14242025 | 615d | 0d |  | SCIENTIST [40 h] | 2,914.4 | ELOUADRHIRI L | 1 | 1 | LATIFA E |  | 13-002F |  | IN |  |  |  |  |  |  |  |  |  |  |  |  |  |  | 12-007 |  |  | APP |  | 4242 |  |  | 12-027 |  |  |  |  |
| 14242055 |  | ORTEC 935F discr. (25) test/install |  | 59d | 2013-04-10 | 2013-07-02 | 14242050 | 615d | 0d |  | SCIENTIST [40 h] | 2,914.4 | ELOUADRHIRI L | 1 | 1 | LATIFA E |  | 13-002F |  | IN |  |  |  |  |  |  |  |  |  |  |  |  |  |  | 12-007 |  |  | APP |  | 4242 |  |  | 12-027 |  |  |  |  |
| 14242060M |  | TDC and Discriminators Complete | milestone | 0d | 2013-07-02 | 2013-07-02 | 14242005, 14242040, 14242055, 14242010, 14242030, 14242015 | 615d | 612d |  |  |  | ELOUADRHIRI L | 1 | 1 | LATIFA E |  | 13-002F |  | IN |  |  |  |  |  |  |  |  |  |  |  |  |  |  | 12-007 |  |  |  |  |  |  |  | 12-027 |  |  |  |  |
| 14242065 |  | Re-Baseline Actuals Adjustment |  | 1d | 2013-08-30 | 2013-08-30 | 9-130M FS+227d | 20d |  |  | PROCUREMENT>$50K 69 NO ESCALATION | -55,558.26 | ELOUADRHIRI L | 1 | 1 | LATIFA E |  |  |  |  |  |  | 13-014 | ADJ |  |  |  |  |  |  |  |  |  |  |  |  |  |  |  |  |  |  |  |  |  |  |  |
| 24242040a |  | JLab Discriminator (12) and Flash FADC (12) test/install (SF) |  | 128d | 2014-04-01 | 2014-09-30 | 9-140M FS+119d | 304d | 247d | 8/5 M-F w/JLAB Holidays ReBaseline | PLABOR | 3,714.84 | ELOUADRHIRI L | 1 | 1 | LATIFA E |  | 13-002F |  | IN |  |  |  |  | 24242040a | S |  | 13-015 | PR | 14-001 | ST | PE |  |  | 12-007 |  |  | APP |  | 4242 | 12-016 | 12-054 |  | 12-053 | 2113.92 | PE | Review |
| 24242055 |  | ORTEC 935F Discriminators (24) Test/Install (SF) |  | 128d | 2014-04-01 | 2014-09-30 | 9-140M FS+119d | 304d | 247d | 8/5 M-F w/JLAB Holidays ReBaseline | PLABOR | 11,144.52 | ELOUADRHIRI L | 1 | 1 | LATIFA E |  | 13-002F |  | IN |  |  |  |  | 24242055 | S |  | 13-015 | PR | 14-001 | ST | PE |  |  | 12-007 |  |  | APP |  | 4242 | 12-016 | 12-054 |  | 12-053 | 2113.92 | PE | Review |
| 24242005 |  | CAEN v1190 (30) and v1290 (24) TDC's installation (FC) |  | 119d | 2014-10-01 | 2015-03-31 | 9-155M, 24264278 | 57d | 0d | 8/5 M-F w/JLAB Holidays ReBaseline | PLABOR | 26,003.88 | ELOUADRHIRI L | 1 | 1 | LATIFA E |  | 13-002F |  | IN |  |  |  |  | 24242005 | S |  | 13-015 | PR | 14-001 | ST |  |  |  | 12-007 |  |  |  |  |  |  |  | 12-027 |  |  | PE |  |
| 24242010 |  | CAEN v1290 TDC's (1) procurement |  | 161d | 2014-10-01 | 2015-05-29 | 9-155M | 143d | 86d | 8/5 M-F w/JLAB Holidays ReBaseline | PROCUREMENT<$50K 60 | 10,319 | ELOUADRHIRI L | 1 | 1 | LATIFA E |  | 13-002F |  | IN |  |  |  |  | 24242010 | U | CP | 13-015 | PR | 14-001 |  |  |  |  | 12-007 |  |  |  |  |  |  |  | 12-027 |  |  |  |  |
| 24242030 |  | JLab TDC Fanout (18) test/install (FC) |  | 119d | 2014-10-01 | 2015-03-31 | 9-155M | 57d | 0d | 8/5 M-F w/JLAB Holidays ReBaseline | SCIENTIST; PLABOR | 1,857.42 | ELOUADRHIRI L | 1 | 1 | LATIFA E |  | 13-002F |  | IN |  |  |  |  | 24242030 | S |  | 13-015 | PR | 14-001 | ST | PE |  |  | 12-007 |  |  | APP |  | 4242 |  |  | 12-027 |  |  | PE |  |
| 24242040 |  | JLab Discriminator (240) and Flash FADC (240) test/install (FC) |  | 77d | 2014-10-01 | 2015-01-30 | 9-130M FS+228d, 9-155M | 227d | 170d | 8/5 M-F w/JLAB Holidays ReBaseline | PLABOR | 31,761.88 | ELOUADRHIRI L | 1 | 1 | LATIFA E |  | 13-002F |  | IN |  |  |  |  | 24242040 | S |  | 13-015 | PR | 14-001 | ST | PE |  |  | 12-007 |  |  | APP |  | 4242 | 12-016 | 12-054 |  | 12-053 | 2113.92 | PE | Review |
| 24242057 |  | Radial Connectors and Sockets for HV Distribution Boxes |  | 77d | 2014-10-01 | 2015-01-30 | 9-155M | 167d | 126d | 8/5 M-F w/JLAB Holidays ReBaseline | PROCUREMENT<$50K 60 | 16,758.06 | ELOUADRHIRI L | 1 | 1 | LATIFA E |  | 13-002F |  | IN |  |  |  |  | 24242057 | D | OB | 13-015 | PR | 14-001 |  |  |  |  | 12-007 |  |  |  |  |  |  | 12-054 | 12-027 |  |  |  |  |
| 24242005a |  | CAEN v1190 (1) and v1290N (7) TDC's installation (SF) |  | 128d | 2015-04-01 | 2015-10-01 | 24264230, 24242005 | 57d | 0d | 8/5 M-F w/JLAB Holidays ReBaseline | PLABOR | 5,572.26 | ELOUADRHIRI L | 1 | 1 | LATIFA E |  | 13-002F |  | IN |  |  |  |  | 24242005a | S |  | 13-015 | PR | 14-001 | ST |  |  |  | 12-007 |  |  |  |  |  |  |  | 12-027 |  |  | PE |  |
| 24242030a |  | JLab TDC Fanout (2) test/install (SF) |  | 128d | 2015-04-01 | 2015-10-01 | 24242030 | 57d | 0d | 8/5 M-F w/JLAB Holidays ReBaseline | SCIENTIST; PLABOR | 1,857.42 | ELOUADRHIRI L | 1 | 1 | LATIFA E |  | 13-002F |  | IN |  |  |  |  | 24242030a | S |  | 13-015 | PR | 14-001 | ST | PE |  |  | 12-007 |  |  | APP |  | 4242 |  |  | 12-027 |  |  | PE |  |
| 24242060M |  | TDC and Discriminators Complete | milestone | 0d | 2015-10-01 | 2015-10-01 | 24242010, 24242040, 24242030a, 24242055, 24242040a, 24242005a | 57d | 54d | 8/5 M-F w/JLAB Holidays ReBaseline |  |  | ELOUADRHIRI L | 1 | 1 | LATIFA E |  | 13-002F |  | IN |  |  |  |  | 24242060M | M |  | 13-015 | PR |  |  |  |  |  | 12-007 |  |  |  |  |  |  |  | 12-027 |  |  |  |  |

Notes:
- 24235010a: Steps: Develop/install epics drivers for HV/LV systems; Develop/install epics drivers for motor systems; Develop/install epics drivers for magnets; Develop/install epics drivers for other systems
- 24235015: Steps: Develop/install epics iocs; Develop/install epics GUIs; Develop/install epics components (alarm, archiver etc); Develop/install epics monitoring tree including communication with DAQ
- 24242040a: Steps: Install DSC2 and FADC boards on Space Frame; Cable all DSC2 and FADC on Space Frame; Test all DSC2 and FADC running calibration procedures and obtain calibration constants
- 24242055: Steps: Install ORTEC 935 boards on Space Frame; Cable all ORTEC 935 on Space Frame; Test all ORTEC 935 running calibration procedures and obtain calibration constants
- 24242005: Steps: Install v1190/v1290 TDC boards on Forward Carriage; Cable all TDCs on Forward Carriage; Test all TDCs running calibration procedures and obtain calibration constants
- 24242030: Steps: Install TDC FOUT boards on Forward Carriage; Cable all FOUTs on Forward Carriage; Test all FOUTs running DAQ
- 24242040: Steps: Install DSC2 and FADC boards on Forward Carriage; Cable all DSC2 and FADCs on Forward Carriage; Test all DSC2 and FADC running calibration procedures and obtain calibration constants
- 24242005a: Steps: Install v1190/v1290 TDC boards on Space Frame; Cable all TDCs on Space Frame; Test all TDCs running calibration procedures and obtain calibration constants
- 24242030a: Steps: Install TDC FOUT boards on Space Frame; Cable all FOUTs on Space Frame; Test all FOUTs running DAQ

| ID | WBS | Activity | Type | Duration | Start | Finish | Predecessors | Total float | Free float | Calendar | Resources | Cost | RESP - Responsibility | STRT%COMP for CM EVM | FNSH%COMP for CM EVM | CAM RESPONSIBLE | CR 11-026 | CR 13-002 | CR 13-014 | ReBaseline Actuals Adjustment | Original Activity ID Rebaseline | PHAS - Project Phase | EVMS Reporting Codes | CR 12-027 | CR 12-054 | BOE Procurement | CR 13-015 | Post Rebaseline | CR 14-001 | CR 11-029 | CR 11-002 | CR 12-007 | BOE Labor | Activities with Steps | BOE Expenses | CR 10-053 | CR 10-077 | Over Under Fixed | Obligated Prior to Rebaseline |
| --- | --- | --- | --- | --- | --- | --- | --- | --- | --- | --- | --- | --- | --- | --- | --- | --- | --- | --- | --- | --- | --- | --- | --- | --- | --- | --- | --- | --- | --- | --- | --- | --- | --- | --- | --- | --- | --- | --- | --- |
|  | 3 | **1.4.2.4.3 SCALERS** |  |  | 2012-01-05 | 2015-07-09 |  |  |  |  |  |  |  |  |  |  |  |  |  |  |  |  |  |  |  |  |  |  |  |  |  |  |  |  |  |  |  |  |  |
| 14243005 |  | SCALERS- Prcrmnt |  | 20d | 2012-01-05 | 2012-02-02 | 9-120M FS+60d, 12224005 | 415d |  |  | ELEC TECH [80 h]; SCIENTIST [40 h] | 6,354.8 | ELOUADRHIRI L | 1 | 1 | LATIFA E | 11-026 | 13-002F |  |  |  |  |  |  |  |  |  |  |  |  |  |  |  |  |  |  |  |  |  |
| 14243015 |  | Re-Baseline Actuals Adjustment |  | 1d | 2013-08-30 | 2013-08-30 | 9-130M FS+227d | 20d |  |  | PROCUREMENT>$50K 69 NO ESCALATION | -6,354.8 | ELOUADRHIRI L | 1 | 1 | LATIFA E |  |  | 13-014 | ADJ |  |  |  |  |  |  |  |  |  |  |  |  |  |  |  |  |  |  |  |
| 24243010 |  | SCALERS - Procurement/Install (SF) |  | 128d | 2015-01-07 | 2015-07-09 | 9-155M FS+60d | 116d | 113d | 8/5 M-F w/JLAB Holidays ReBaseline | PROCUREMENT<$50K 60; PROCUREMENT>$50K 69 | 68,105.4 | ELOUADRHIRI L | 1 | 1 | LATIFA E | 11-026 | 13-002F |  |  | 24243010 | IN | U | 12-027 | 12-054 | CP | 13-015 | PR | 14-001 |  |  |  |  |  |  |  |  |  |  |
|  | 4 | **1.4.2.4.4 HIGH VOLTAGE** |  |  | 2012-01-05 | 2014-09-30 |  |  |  |  |  |  |  |  |  |  |  |  |  |  |  |  |  |  |  |  |  |  |  |  |  |  |  |  |  |  |  |  |  |
| 14244005 |  | Hi Voltage Prcrmnt |  | 20d | 2012-01-05 | 2012-02-02 | 9-120M FS+60d, 12224005 | 858d | 0d |  | SCIENTIST [40 h]; ELEC TECH [80 h] | 6,354.8 | ELOUADRHIRI L | 1 | 1 | LATIFA E | 11-026 | 13-002F |  |  |  |  |  |  |  |  |  |  |  | 11-029 |  |  |  |  |  |  |  |  |  |
| 14244010 |  | Vend Fab - Universal Multichannel Power Supply System 750W (QTY 5) |  | 130d | 2012-01-05 | 2012-07-10 | 14244005 FS-20d | 858d | 0d |  | PROCUREMENT<$50K 60 | 43,511.1 | ELOUADRHIRI L | 1 | 1 | LATIFA E | 11-026 | 13-002F |  |  |  | IN |  |  |  |  |  |  |  | 11-029 | 11-002 |  |  |  |  |  |  |  |  |
| 14244015 |  | Vend Fab - Optional Power Supply 750W (QTY5) |  | 130d | 2012-01-05 | 2012-07-10 | 14244010 FS-130d | 858d | 0d |  | PROCUREMENT<$50K 60 | 6,842.53 | ELOUADRHIRI L | 1 | 1 | LATIFA E | 11-026 | 13-002F |  |  |  | IN |  |  |  |  |  |  |  | 11-029 | 11-002 |  |  |  |  |  |  |  |  |
| 14244020 |  | Vend Fab - H.V Channels +3.5 KV 3 MA Floating (QTY13) |  | 130d | 2012-01-05 | 2012-07-10 | 14244015 FS-130d | 858d | 0d |  | PROCUREMENT<$50K 60; PROCUREMENT>$50K 69 | 88,992.05 | ELOUADRHIRI L | 1 | 1 | LATIFA E | 11-026 | 13-002F |  |  |  | IN |  |  |  |  |  |  |  | 11-029 | 11-002 |  |  |  |  |  |  |  |  |
| 14244025 |  | Vend Fab - H.V Channels -3.5 KV 3 MA Floating (QTY87) |  | 130d | 2012-01-05 | 2012-07-10 | 14244020 FS-130d | 858d | 855d |  | PROCUREMENT>$50K 69 | 562,472.78 | ELOUADRHIRI L | 1 | 1 | LATIFA E | 11-026 | 13-002F |  |  |  | IN |  |  |  |  |  |  |  | 11-029 | 11-002 |  |  |  |  |  |  |  |  |
| 14244040 |  | Re-Baseline Actuals Adjustment |  | 1d | 2013-08-30 | 2013-08-30 | 9-130M FS+227d | 20d |  |  | PROCUREMENT>$50K 69 NO ESCALATION | -26,658.33 | ELOUADRHIRI L | 1 | 1 | LATIFA E |  |  | 13-014 | ADJ |  |  |  |  |  |  |  |  |  |  |  |  |  |  |  |  |  |  |  |
| 24244035 |  | HV mainframes SY4525 (5) Procurements |  | 184d | 2013-10-01 | 2014-07-01 | 9-140M | 367d | 364d | 8/5 M-F w/JLAB Holidays ReBaseline | PROCUREMENT<$50K 60 | 50,000 | ELOUADRHIRI L | 1 | 1 | LATIFA E | 11-026 | 13-002F |  |  | 24244035 | IN | U |  | 12-054 | PE | 13-015 | PR |  | 11-029 | 11-002 | 12-007 | PE |  |  |  |  |  |  |
| 24244030 |  | CAEN 1527 HV mainframes install (12) (FC), (2) (SF)installation |  | 128d | 2014-04-01 | 2014-09-30 | 9-140M FS+119d | 304d | 301d | 8/5 M-F w/JLAB Holidays ReBaseline | PLABOR | 13,001.94 | ELOUADRHIRI L | 1 | 1 | LATIFA E | 11-026 | 13-002F |  |  | 24244030 | IN | S |  | 12-054 |  | 13-015 | PR | 14-001 | 11-029 | 11-002 | 12-007 |  | ST | PE |  |  |  |  |
|  | 5 | **1.4.2.4.5 PRE-TRIGGER** |  |  |  |  |  |  |  |  |  |  |  |  |  |  |  |  |  |  |  |  |  |  |  |  |  |  |  |  |  |  |  |  |  |  |  |  |  |
|  | 6 | **1.4.2.4.6 LOGIC** |  |  |  |  |  |  |  |  |  |  |  |  |  |  |  |  |  |  |  |  |  |  |  |  |  |  |  |  |  |  |  |  |  |  |  |  |  |
|  | 7 | **1.4.2.4.7 CRATES, RACKS** |  |  | 2010-09-30 | 2014-12-17 |  |  |  |  |  |  |  |  |  |  |  |  |  |  |  |  |  |  |  |  |  |  |  |  |  |  |  |  |  |  |  |  |  |
| 14247008 |  | Vend Fab Crates and Racks Phase 1 Peg Point #2 VME64 Qty 5 |  | 98d | 2010-09-30 | 2011-02-28 | 9-110M FS-1d | 1116d | 0d |  | PROCUREMENT>$50K 69 NO ESCALATION FY11; PROCUREMENT<$50K 60 NO ESCALATION FY11 | 36,160 | ELOUADRHIRI L | 1 | 1 | LATIFA E | 11-026 | 13-002F |  |  |  | IN |  |  |  |  |  |  |  |  |  |  |  |  |  | 10-053 | 10-077 |  |  |
| 14247009 |  | Vend Fab Crates and Racks Phase 1 Peg Point #4 VXS Qty 5 |  | 121d | 2010-09-30 | 2011-03-31 | 14247008 FS-98d | 1116d | 188d |  | PROCUREMENT<$50K 60 NO ESCALATION FY11; PROCUREMENT>$50K 69 NO ESCALATION FY11 | 54,340 | ELOUADRHIRI L | 1 | 1 | LATIFA E | 11-026 | 13-002F |  |  |  | IN |  |  |  |  |  |  |  |  |  |  |  |  |  | 10-053 | 10-077 |  |  |
| 14247010 |  | Vend Fab Crates and Racks Phase 2 VXS |  | 60d | 2012-01-05 | 2012-03-30 | 9-120M FS+60d, 14247009 | 928d | 925d |  | PROCUREMENT>$50K 69 NO ESCALATION; PROCUREMENT<$50K 60 NO ESCALATION | 198,417 | ELOUADRHIRI L | 1 | 1 | LATIFA E | 11-026 | 13-002F |  |  |  | IN |  |  |  |  |  |  |  |  |  |  |  |  |  | 10-053 | 10-077 |  |  |
| 14247015 |  | Vend Fab Crates and Racks Phase 2 VME64X |  | 60d | 2012-01-05 | 2012-03-30 | 9-120M FS+60d, 14247009 | 928d | 925d |  | PROCUREMENT>$50K 69 NO ESCALATION | 104,355 | ELOUADRHIRI L | 1 | 1 | LATIFA E | 11-026 | 13-002F |  |  |  | IN |  |  |  |  |  |  |  |  |  |  |  |  |  | 10-053 | 10-077 |  |  |
| 14247005 |  | Crates & Racks Prcrmnt |  | 23d | 2012-10-01 | 2012-10-31 | 9-130M, 12224005 | 225d |  |  | SCIENTIST [40 h]; ELEC TECH [80 h] | 6,557.6 | ELOUADRHIRI L | 1 | 1 | LATIFA E | 11-026 | 13-002F |  |  |  |  |  |  |  |  |  |  |  |  |  | 12-007 |  |  |  |  | 10-077 |  |  |
| 14247020 |  | NIM crates (10) procurement |  | 23d | 2012-10-01 | 2012-10-31 | 9-130M | 62d | 0d |  | PROCUREMENT<$50K 60; PROCUREMENT>$50K 69 | 72,233 | ELOUADRHIRI L | 1 | 1 | LATIFA E |  | 13-002F |  |  |  | IN |  |  | 12-054F |  |  |  |  |  |  | 12-007 |  |  |  |  |  |  |  |
| 14247030 |  | Racks FC Level-0 (10) procurement |  | 23d | 2012-10-01 | 2012-10-31 | 9-130M | 62d | 0d |  | PROCUREMENT<$50K 60; PROCUREMENT>$50K 69 | 72,233 | ELOUADRHIRI L | 1 | 1 | LATIFA E |  | 13-002F |  |  |  | IN |  |  | 12-054F |  |  |  |  |  |  | 12-007 |  |  |  |  |  |  |  |
| 14247006 |  | Wiener VME64x crates install (20) |  | 20d | 2013-05-31 | 2013-06-27 | 9-130M FS+163d | 65d |  |  | ELEC TECH [40 h] | 1,821.6 | ELOUADRHIRI L | 1 | 1 | LATIFA E |  | 13-002F |  |  |  |  |  |  | 12-054 |  |  |  |  |  |  | 12-007 |  |  |  |  |  |  |  |
| 14247025 |  | NIM crates (10) install |  | 20d | 2013-06-05 | 2013-07-02 | 14247020 FS+143d | 62d |  |  | ELEC TECH [16 h] | 728.64 | ELOUADRHIRI L | 1 | 1 | LATIFA E |  | 13-002F |  |  |  | IN |  |  | 12-054 |  |  |  |  |  |  | 12-007 |  |  |  |  |  |  |  |
| 14247035 |  | Racks FC Level-0 (10) install |  | 20d | 2013-06-05 | 2013-07-02 | 14247030 FS+143d | 62d |  |  | ELEC TECH [16 h] | 728.64 | ELOUADRHIRI L | 1 | 1 | LATIFA E |  | 13-002F |  |  |  | IN |  |  | 12-054 |  |  |  |  |  |  | 12-007 |  |  |  |  |  |  |  |
| 14247065 |  | Re-Baseline Actuals Adjustment |  | 1d | 2013-08-30 | 2013-08-30 | 9-130M FS+227d | 20d |  |  | PROCUREMENT>$50K 69 NO ESCALATION | 61,081.12 | ELOUADRHIRI L | 1 | 1 | LATIFA E |  |  | 13-014 | ADJ |  |  |  |  |  |  |  |  |  |  |  |  |  |  |  |  |  |  |  |
| 24247040 |  | Uninterruptible PowerSupply (16kVA) |  | 77d | 2013-09-03 | 2013-12-20 | 9-130M FS+228d | 474d | 0d | 8/5 M-F w/JLAB Holidays ReBaseline | PROCUREMENT<$50K 60 NO ESCALATION FY14 | 12,382.92 | ELOUADRHIRI L | 1 | 1 | LATIFA E |  | 13-002F |  |  | 24247040 | IN | D |  | 12-054 | EV | 13-015 | PR |  |  |  | 12-007 |  |  |  |  |  | y | OB |
| 24247045 |  | Re-locate existing UPS to Hall B |  | 20d | 2014-01-02 | 2014-01-30 | 24247040 | 474d | 224d | 8/5 M-F w/JLAB Holidays ReBaseline | PLABOR | 3,714.84 | ELOUADRHIRI L | 1 | 1 | LATIFA E |  | 13-002F |  |  | 24247045 | IN | S |  | 12-054 |  | 13-015 | PR | 14-001 |  |  | 12-007 |  | ST | PE |  |  |  |  |
| 24247005 |  | Wiener VME64x crates install (20) (FC) |  | 119d | 2014-01-07 | 2014-06-24 | 9-140M FS+60d | 250d | 0d | 8/5 M-F w/JLAB Holidays ReBaseline | PLABOR | 11,144.52 | ELOUADRHIRI L | 1 | 1 | LATIFA E |  | 13-002F |  |  | 24247005 |  | S |  | 12-054 |  | 13-015 | PR | 14-001 |  |  | 12-007 |  | ST | PE |  |  |  |  |
| 24247025 |  | NIM crates (10) install (FC) |  | 127.5d | 2014-01-07 | 2014-07-08 | 9-140M FS+60d | 363.5d | 113.5d | 8/5 M-F w/JLAB Holidays ReBaseline | PLABOR | 7,429.68 | ELOUADRHIRI L | 1 | 1 | LATIFA E |  | 13-002F |  |  | 24247025 | IN | S |  | 12-054 |  | 13-015 | PR | 14-001 |  |  | 12-007 |  | ST | PE |  |  |  |  |
| 24247030 |  | NIM crates (2) install (SF) |  | 127.5d | 2014-04-01 | 2014-09-30 | 9-140M FS+119d | 304.5d | 54.5d | 8/5 M-F w/JLAB Holidays ReBaseline | PLABOR | 1,857.42 | ELOUADRHIRI L | 1 | 1 | LATIFA E |  | 13-002F |  |  | 24247030 | IN | S |  | 12-054 |  | 13-015 | PR | 14-001 |  |  | 12-007 |  | ST | PE |  |  |  |  |
| 24247005a |  | Wiener VME64x crates install (2) (SF) |  | 122d | 2014-06-25 | 2014-12-17 | 24247005 | 250d | 0d | 8/5 M-F w/JLAB Holidays ReBaseline | PLABOR | 1,857.42 | ELOUADRHIRI L | 1 | 1 | LATIFA E |  | 13-002F |  |  | 24247005a |  | S |  | 12-054 |  | 13-015 | PR | 14-001 |  |  | 12-007 |  | ST | PE |  |  |  |  |
| 24247060M |  | Crates and Racks Complete | milestone | 0d | 2014-12-17 | 2014-12-17 | 24247005a, 24247030, 24247005, 24247025, 24247045 | 250d | 247d | 8/5 M-F w/JLAB Holidays ReBaseline |  |  | ELOUADRHIRI L | 1 | 1 | LATIFA E |  | 13-002F |  |  | 24247060M | IN | M |  | 12-054 |  | 13-015 | PR |  |  |  | 12-007 |  |  |  |  |  |  |  |

Notes:
- 24244030: Steps: Install CAEN mainframes in the Hall and populate with HV boards; Connect and configure mainframes to the network, and boards to detectors; Include mainframes into epics IOCs and test entire system
- 24247045: Steps: Relocate UPS devices to the Pie Tower and Space Frame in Hall B; Replace all batteries; Connect to the network and emergency generator; Run tests
- 24247005: Steps: Install WIENER crates on Forward Carriage; Connect crates to the network and configure; Test crates with epics control
- 24247025: Steps: Install NIM crates on Forward Carriage; Connect crates to the network and configure; Test crates with epics control
- 24247030: Steps: Install NIM crates on Space Frame; Connect crates to the network and configure; Test crates with epics control
- 24247005a: Steps: Install WIENER crates on Space Frame; Connect crates to the network and configure; Test crates with epics control

| ID | WBS | Activity | Duration | Start | Finish | Predecessors | Total float | Free float | Calendar | Resources | Cost | PHAS - Project Phase | RESP - Responsibility | STRT%COMP for CM EVM | FNSH%COMP for CM EVM | CAM RESPONSIBLE | CR 11-026 | CR 12-013 | CR 13-002 | CR 13-014 | ReBaseline Actuals Adjustment | Original Activity ID Rebaseline | EVMS Reporting Codes | BOE Expenses | CR 13-015 | Post Rebaseline | CR 14-001 | BOE Labor | BOE Procurement |
| --- | --- | --- | --- | --- | --- | --- | --- | --- | --- | --- | --- | --- | --- | --- | --- | --- | --- | --- | --- | --- | --- | --- | --- | --- | --- | --- | --- | --- | --- |
|  | 5 | **1.4.2.5 BEAMLINE** |  | 2011-10-03 | 2015-10-01 |  |  |  |  |  |  |  |  |  |  |  |  |  |  |  |  |  |  |  |  |  |  |  |  |
|  | 1 | **1.4.2.5.1 FARADAY CUP UPGRADE** |  | 2013-01-03 | 2013-08-30 |  |  |  |  |  |  |  |  |  |  |  |  |  |  |  |  |  |  |  |  |  |  |  |  |
| 14251005 |  | Refurb CLAS Faraday Cup | 80d | 2013-01-03 | 2013-04-26 | 9-130M FS+60d | 661d | 658d |  | MECH TECH [480 h]; ELEC ENG [240 h]; SCIENTIST [200 h]; MSHOP | 105,189.59 | IN | ELOUADRHIRI L | 1 | 1 | LATIFA E | 11-026 | 12-013 | 13-002F |  |  |  |  |  |  |  |  |  |  |
| 14251010 |  | Re-Baseline Actuals Adjustment | 1d | 2013-08-30 | 2013-08-30 | 9-130M FS+227d | 20d |  |  | PROCUREMENT>$50K 69 NO ESCALATION | -105,189.59 |  | ELOUADRHIRI L | 1 | 1 | LATIFA E |  |  |  | 13-014 | ADJ |  |  |  |  |  |  |  |  |
|  | 2 | **1.4.2.5.2 MOLLER POLARIMETER UPGRADE** |  | 2013-01-03 | 2013-08-30 |  |  |  |  |  |  |  |  |  |  |  |  |  |  |  |  |  |  |  |  |  |  |  |  |
| 14252005 |  | Fab a Moller Polarimeter Supprt Struct | 120d | 2013-01-03 | 2013-06-24 | 12225020, 9-130M FS+60d | 573d | 0d |  | MSHOP; MECH TECH [220 h]; SCIENTIST [20 h]; ELEC TECH [120 h]; CONTRB UNIV LBR [880 h] | 29,470.85 |  | ELOUADRHIRI L | 1 | 1 | LATIFA E | 11-026 | 12-013 | 13-002F |  |  |  |  |  |  |  |  |  |  |
| 14252010 |  | Fab a Moller Polarimeter Supprt Struct | 48d | 2013-06-25 | 2013-08-30 | 9-110M, 14252005 | 573d | 570d |  | MSHOP; MECH TECH [88 h]; ELEC TECH [48 h]; CONTRB UNIV LBR [352 h]; SCIENTIST [8 h] | 12,049.12 | IN | ELOUADRHIRI L | 1 | 1 | LATIFA E | 11-026 | 12-013 | 13-002F | 13-014 |  |  |  |  |  |  |  |  |  |
| 14252015 |  | Re-Baseline Actuals Adjustment | 1d | 2013-08-30 | 2013-08-30 | 9-130M FS+227d | 20d |  |  | PROCUREMENT>$50K 69 NO ESCALATION | -41,519.97 |  | ELOUADRHIRI L | 1 | 1 | LATIFA E |  |  |  | 13-014 | ADJ |  |  |  |  |  |  |  |  |
|  | 3 | **1.4.2.5.3 TARGETS** |  |  |  |  |  |  |  |  |  |  |  |  |  |  |  |  |  |  |  |  |  |  |  |  |  |  |  |
|  | 4 | **1.4.2.5.4 BEAMLINE COMPONENTS** |  | 2011-10-03 | 2015-10-01 |  |  |  |  |  |  |  |  |  |  |  |  |  |  |  |  |  |  |  |  |  |  |  |  |
| 14254005 |  | P-#1 Constrctn of Beam Line Monitoring Sys | 120d | 2011-10-03 | 2012-03-30 | 9-120M | 820d | 247d |  | SCIENTIST [80 h] | 5,648.8 |  | ELOUADRHIRI L | 1 | 1 | LATIFA E | 11-026 |  | 13-002F |  |  |  |  |  |  |  |  |  |  |
| 14254007 |  | Beamline Studies and Drawings | 149d | 2012-03-01 | 2012-09-28 | 9-120M FS+98d | 801d | 798d |  | SCIENTIST [440 h]; MECH DES [220 h] | 41,665.8 | IN | ELOUADRHIRI L | 1 | 1 | LATIFA E | 11-026 | 12-013 | 13-002F |  |  |  |  |  |  |  |  |  |  |
| 14254008 |  | MOU with FIU on Moller Polarimeter | 149d | 2012-03-01 | 2012-09-28 | 9-120M FS+98d | 801d | 798d |  | SCIENTIST [440 h]; MECH DES [220 h] | 41,665.8 | IN | ELOUADRHIRI L | 1 | 1 | LATIFA E | 11-026 | 12-013 | 13-002F |  |  |  |  |  |  |  |  |  |  |
| 14254010 |  | Constrctn of Beam Line Shielding | 120d | 2013-01-03 | 2013-06-24 | 12225050, 9-130M FS+60d | 621d | 618d |  | MSHOP; PROCUREMENT<$50K 60 | 56,913.48 | IN | ELOUADRHIRI L | 1 | 1 | LATIFA E | 11-026 | 12-013 | 13-002F |  |  |  |  |  |  |  |  |  |  |
| 14254015 |  | Constrctn of Beam Line Vac Sys | 120d | 2013-01-03 | 2013-06-24 | 9-130M FS+60d | 573d | 0d |  | ELEC DES [181 h]; MSHOP; SCIENTIST [65.8 h]; PROCUREMENT<$50K 60; VISTNG USERS [378.3 h]; MECH TECH [181 h] | 79,385.01 |  | ELOUADRHIRI L | 1 | 1 | LATIFA E | 11-026 | 12-013 | 13-002F |  |  |  |  |  |  |  |  |  |  |
| 14254020 |  | P-#2 Constrctn of Beam Line Monitoring Sys | 108d | 2013-04-01 | 2013-08-30 | 9-130M FS+120d, 14254005 | 573d | 570d |  | SCIENTIST [144 h] | 10,491.84 |  | ELOUADRHIRI L | 1 | 1 | LATIFA E | 11-026 | 12-013 | 13-002F | 13-014 |  |  |  |  |  |  |  |  |  |
| 14254025 |  | Constrctn of Beam Line Vac Sys | 48d | 2013-06-25 | 2013-08-30 | 9-110M, 14254015 | 573d | 570d |  | SCIENTIST [18.28 h]; VISTNG USERS [133.94 h]; ELEC DES [66.96 h]; MECH TECH [66.96 h] | 10,564.73 | IN | ELOUADRHIRI L | 1 | 1 | LATIFA E | 11-026 | 12-013 | 13-002F | 13-014 |  |  |  |  |  |  |  |  |  |
| 14254030 |  | Re-Baseline Actuals Adjustment | 1d | 2013-08-30 | 2013-08-30 | 9-130M FS+227d | 20d |  |  | PROCUREMENT>$50K 69 NO ESCALATION | -246,335.38 |  | ELOUADRHIRI L | 1 | 1 | LATIFA E |  |  |  | 13-014 | ADJ |  |  |  |  |  |  |  |  |
| 24254000 |  | Faraday Cup Materials | 57d | 2014-10-01 | 2014-12-22 | 9-155M | 207d | 0d | 8/5 M-F w/JLAB Holidays ReBaseline | SUPPLIES & MATERIALS | 2,063.8 | IN | ELOUADRHIRI L | 1 | 1 | LATIFA E | 11-026 | 12-013 | 13-002F |  |  | 24254000 | D | PE | 13-015 | PR | 14-001 |  |  |
| 24254040 |  | Moller Shielding Manufacturing Design | 64d | 2014-10-01 | 2015-01-12 | 9-155M | 98d | 0d | 8/5 M-F w/JLAB Holidays ReBaseline | MECH DES [160 h]; MECH ENG [40 h] | 11,194.8 | IN | ELOUADRHIRI L | 1 | 1 | LATIFA E | 11-026 | 12-013 | 13-002F |  |  | 24254040 | S |  | 13-015 | PR | 14-001 | PE |  |
| 24254055 |  | Downstream Vacuum System Procurement | 57d | 2014-10-01 | 2014-12-22 | 9-155M | 206d | 0d | 8/5 M-F w/JLAB Holidays ReBaseline | PROCUREMENT<$50K 60 | 30,957 |  | ELOUADRHIRI L | 1 | 1 | LATIFA E | 11-026 | 12-013 | 13-002F |  |  | 24254055 | D |  | 13-015 | PR | 14-001 |  | PE |
| 24254065 |  | Upstream Vacuum System Procurement | 57d | 2014-10-01 | 2014-12-22 | 9-155M | 227d | 0d | 8/5 M-F w/JLAB Holidays ReBaseline | PROCUREMENT<$50K 60 | 30,957 | IN | ELOUADRHIRI L | 1 | 1 | LATIFA E | 11-026 | 12-013 | 13-002F |  |  | 24254065 | D |  | 13-015 | PR | 14-001 |  | PE |
| 24254075 |  | Beam Offset Monitor Procurement | 57d | 2014-10-01 | 2014-12-22 | 9-155M | 207d | 0d | 8/5 M-F w/JLAB Holidays ReBaseline | PROCUREMENT<$50K 60 | 8,255.2 | IN | ELOUADRHIRI L | 1 | 1 | LATIFA E | 11-026 | 12-013 | 13-002F |  |  | 24254075 | D |  | 13-015 | PR | 14-001 |  | PE |
| 24254085 |  | 2C24 girder move Procurement | 57d | 2014-10-01 | 2014-12-22 | 9-155M | 238d | 0d | 8/5 M-F w/JLAB Holidays ReBaseline | PROCUREMENT<$50K 60 | 10,319 | IN | ELOUADRHIRI L | 1 | 1 | LATIFA E | 11-026 | 12-013 | 13-002F |  |  | 24254085 | D |  | 13-015 | PR | 14-001 |  | PE |
| 24254095 |  | Upstream beam blocker and vacuum box Manufacturing Design | 41d | 2014-10-01 | 2014-11-26 | 9-155M | 79d | 0d | 8/5 M-F w/JLAB Holidays ReBaseline | MECH DES [160 h]; MECH ENG [40 h] | 11,194.8 |  | ELOUADRHIRI L | 1 | 1 | LATIFA E | 11-026 | 12-013 | 13-002F |  |  | 24254095 | S |  | 13-015 | PR | 14-001 | PE |  |
| 24254110 |  | Upstream Shielding Wall Procurement | 146d | 2014-10-01 | 2015-05-07 | 9-155M | 158d | 0d | 8/5 M-F w/JLAB Holidays ReBaseline | PROCUREMENT<$50K 60; PROCUREMENT>$50K 69 | 59,381.4 | IN | ELOUADRHIRI L | 1 | 1 | LATIFA E | 11-026 | 12-013 | 13-002F |  |  | 24254110 | D |  | 13-015 | PR | 14-001 |  | PE |
| 24254120 |  | Procurement of Beamline Devices | 247d | 2014-10-01 | 2015-10-01 | 9-155M | 152d | 0d | 8/5 M-F w/JLAB Holidays ReBaseline | PROCUREMENT<$50K 60 | 20,638 | IN | ELOUADRHIRI L | 1 | 1 | LATIFA E | 11-026 | 12-013 | 13-002F |  |  | 24254120 | D |  | 13-015 | PR | 14-001 |  | PE |
| 24254090 |  | 2C24 girder move Labor | 59d | 2014-10-10 | 2015-01-14 | 24254085 FS-50d | 238d | 235d | 8/5 M-F w/JLAB Holidays ReBaseline | MECH TECH [360 h] | 17,035.2 |  | ELOUADRHIRI L | 1 | 1 | LATIFA E | 11-026 | 12-013 | 13-002F |  |  | 24254090 | S |  | 13-015 | PR | 14-001 | PE |  |
| 24254010 |  | Downstream Viewer Manufacturing Design | 61d | 2014-11-26 | 2015-03-05 | 9-155M FS+40d | 103d | 0d | 8/5 M-F w/JLAB Holidays ReBaseline | MECH DES [40 h] | 2,052 | IN | ELOUADRHIRI L | 1 | 1 | LATIFA E | 11-026 | 12-013 | 13-002F |  |  | 24254010 | H |  | 13-015 | PR | 14-001 | PE |  |
| 24254025 |  | Moller polarimeter upgrade Manufacturing Design | 61d | 2014-11-26 | 2015-03-05 | 9-155M FS+40d | 103d | 0d | 8/5 M-F w/JLAB Holidays ReBaseline | MECH DES [160 h]; MECH ENG [40 h] | 11,194.8 |  | ELOUADRHIRI L | 1 | 1 | LATIFA E | 11-026 | 12-013 | 13-002F |  |  | 24254025 | S |  | 13-015 | PR | 14-001 | PE |  |
| 24254100 |  | Upstream beam blocker and vacuum box Procurement | 84d | 2014-12-01 | 2015-04-08 | 24254095 | 79d | 0d | 8/5 M-F w/JLAB Holidays ReBaseline | PROCUREMENT<$50K 60; PROCUREMENT>$50K 69 | 51,595 | IN | ELOUADRHIRI L | 1 | 1 | LATIFA E | 11-026 | 12-013 | 13-002F |  |  | 24254100 | D |  | 13-015 | PR | 14-001 |  | PE |
| 24254005 |  | Faraday Cup Labor | 40d | 2014-12-23 | 2015-02-27 | 24254000 | 207d | 204d | 8/5 M-F w/JLAB Holidays ReBaseline | ELEC ENG [40 h]; ELEC TECH [80 h] | 6,764.4 | IN | ELOUADRHIRI L | 1 | 1 | LATIFA E | 11-026 | 12-013 | 13-002F |  |  | 24254005 | H |  | 13-015 | PR | 14-001 | PE |  |
| 24254060 |  | Downstream Vacuum System Installation | 41d | 2014-12-23 | 2015-03-02 | 24254055 | 206d | 203d | 8/5 M-F w/JLAB Holidays ReBaseline | MECH TECH [160 h] | 7,571.2 |  | ELOUADRHIRI L | 1 | 1 | LATIFA E | 11-026 | 12-013 | 13-002F |  |  | 24254060 | H |  | 13-015 | PR | 14-001 | PE |  |
| 24254070 |  | Upstream Vacuum System Installation | 20d | 2014-12-23 | 2015-01-30 | 24254065 | 227d | 224d | 8/5 M-F w/JLAB Holidays ReBaseline | MECH DES [40 h]; MECH TECH [40 h] | 3,944.8 |  | ELOUADRHIRI L | 1 | 1 | LATIFA E | 11-026 | 12-013 | 13-002F |  |  | 24254070 | H |  | 13-015 | PR | 14-001 | PE |  |
| 24254080 |  | Beam Offset Monitor Installation | 40d | 2014-12-23 | 2015-02-27 | 24254075 | 207d | 204d | 8/5 M-F w/JLAB Holidays ReBaseline | MECH DES [40 h]; MECH TECH [40 h]; ELEC ENG [80 h] | 9,955.2 |  | ELOUADRHIRI L | 1 | 1 | LATIFA E | 11-026 | 12-013 | 13-002F |  |  | 24254080 | H |  | 13-015 | PR | 14-001 | PE |  |
| 24254045 |  | Moller Shielding Procurement | 58d | 2015-01-13 | 2015-04-03 | 24254040 | 98d | 0d | 8/5 M-F w/JLAB Holidays ReBaseline | PROCUREMENT<$50K 60; PROCUREMENT>$50K 69 | 51,595 | IN | ELOUADRHIRI L | 1 | 1 | LATIFA E | 11-026 | 12-013 | 13-002F |  |  | 24254045 | D |  | 13-015 | PR | 14-001 |  | PE |
| 24254015 |  | Downstream Viewer Procurement | 60d | 2015-03-06 | 2015-05-29 | 24254010 | 103d | 0d | 8/5 M-F w/JLAB Holidays ReBaseline | PROCUREMENT<$50K 60 | 10,319 | IN | ELOUADRHIRI L | 1 | 1 | LATIFA E | 11-026 | 12-013 | 13-002F |  |  | 24254015 | D |  | 13-015 | PR | 14-001 |  | PE |
| 24254030 |  | Moller polarimeter upgrade Procurement | 60d | 2015-03-06 | 2015-05-29 | 24254025 | 103d | 0d | 8/5 M-F w/JLAB Holidays ReBaseline | PROCUREMENT<$50K 60; PROCUREMENT>$50K 69 | 61,914 | IN | ELOUADRHIRI L | 1 | 1 | LATIFA E | 11-026 | 12-013 | 13-002F |  |  | 24254030 | D |  | 13-015 | PR | 14-001 |  | PE |
| 24254105 |  | Upstream beam blocker and vacuum box Installation | 120d | 2015-03-12 | 2015-08-31 | 24254100 FS-20d | 79d | 76d | 8/5 M-F w/JLAB Holidays ReBaseline | MECH TECH [160 h]; ELEC ENG [40 h] | 10,576.4 | IN | ELOUADRHIRI L | 1 | 1 | LATIFA E | 11-026 | 12-013 | 13-002F |  |  | 24254105 | S |  | 13-015 | PR | 14-001 | PE |  |
| 24254050 |  | Moller Shielding Installation | 84d | 2015-04-06 | 2015-08-04 | 24254045 | 98d | 95d | 8/5 M-F w/JLAB Holidays ReBaseline | MECH TECH [320 h] | 15,142.4 | IN | ELOUADRHIRI L | 1 | 1 | LATIFA E | 11-026 | 12-013 | 13-002F |  |  | 24254050 | S |  | 13-015 | PR | 14-001 | PE |  |
| 24254115 |  | Upstream Shielding Wall Installation | 20d | 2015-04-10 | 2015-05-07 | 24254110 FS-20d | 158d | 155d | 8/5 M-F w/JLAB Holidays ReBaseline | MECH DES [40 h]; MECH TECH [40 h]; ELEC ENG [80 h] | 9,955.2 |  | ELOUADRHIRI L | 1 | 1 | LATIFA E | 11-026 | 12-013 | 13-002F |  |  | 24254115 | H |  | 13-015 | PR | 14-001 | PE |  |
| 24254020 |  | Downstream Viewer Assembly | 57d | 2015-05-06 | 2015-07-28 | 24254015 FS-17d | 103d | 100d | 8/5 M-F w/JLAB Holidays ReBaseline | MECH TECH [40 h] | 1,892.8 | IN | ELOUADRHIRI L | 1 | 1 | LATIFA E | 11-026 | 12-013 | 13-002F |  |  | 24254020 | H |  | 13-015 | PR | 14-001 | PE |  |
| 24254035 |  | Moller polarimeter upgrade Installation | 57d | 2015-05-06 | 2015-07-28 | 24254030 FS-17d | 103d | 100d | 8/5 M-F w/JLAB Holidays ReBaseline | MECH TECH [284.44 h]; ELEC ENG [35.56 h] | 16,131.2 | IN | ELOUADRHIRI L | 1 | 1 | LATIFA E | 11-026 | 12-013 | 13-002F |  |  | 24254035 | S |  | 13-015 | PR | 14-001 | PE |  |
