# COSTED BL14-001 12 GeV CR13-015,14-001

Schedule from Primavera P6, 2004-03-31 to 2017-09-29, data date 2006-09-30, costs in USD, A marks actual dates.
CHANGE REQUESTS INCLUDED / FY07 002, 003, 006, 007, 008, 010, 005, 009, 014, 012, 15, / 17, 18, 19, 20, 21, 22, 24, 25, 26, 27, 29-33 / FY08 001, 002, 003, 005, 004, 011, 014, 013, 009, 016, 018, / 006, 017, 019, 020, 024(N/C), 023, 010, 025, 021, 022 , 027, 028, / 031, 029, 030(NC), 032, 033, 034, 035, 036, 037, 038, 039, 042, 044, 043, 041, / 045, 046, 048, 048, 049, 051, 050, 052, 054, 055, 056, 057, / 09-001 , 08-058, 059, 060 / FY09 003, 002, 004, 005, 007, 008, 009, 010, 011, 012, / 14A-G,16,17,15,23,9A, 10A, 26, 22, 2431,35,34,33, 32, 27,28,36, 30, 37, / 38,45,43,40,46,41,47,48,43A,44,49,52,39,42,53 / FY10 001A-B, E, 002, / 005,003,004,008,007,010,011,12,18,23,12A,35,36,22,32,33,34,20,21,29,37,24,26,009,019,25,30,27,41,38,40,43,39,44,16,45,28,31,14,50,51,46,48,52,53,54,56,55,42,57,47,17,15,62,59,58,64,66 / ,61,71,70,67,63,VA1,60,65,69 / FY11 / 001-A&D,10-074,004,VA-001,002,007,003,010,016,011,014,15,19,09,17,18,12,13,20,06,08,22,23,VA2,VA3,26,24,27,31,28,30,29,38,25,32,37,46,47,35,40,43,42,44,41,22a,49,52,51,005,48,39,36,55,57,54 / FY12 001-A&D, / 005,002,003,007,010,009,011,008,012,014,015,016,17,13,22,25,18,23,21,26,24,29,28,27,29A,34,37,38,35,36,32,39,42,44,45,43,50,46,47,53,51,54,49,55,40 / FY13 001D,003,008,009,002,004,005,012,006,011,14,15,16 / FY14 001 / This project is to be used to develop the new DOE guidance schedule / Mark Wiseman's PED corrections have been made - RKC
Must finish by 2017-09-30

| ID | WBS | Activity | Type | Duration | Start | Finish | Predecessors | Total float | Free float | Calendar | Resources | Cost | RESP - Responsibility | STRT%COMP for CM EVM | FNSH%COMP for CM EVM | CAM RESPONSIBLE | CR 13-014 | ReBaseline Actuals Adjustment | PHAS - Project Phase | CR 08-016 | CR 09-012 | CR 09-030 | CR 09-030 Repair | CR 11-026 | CR 11-035 | CR 12-051 | CR 13-002 | CR 12-027 | CR 12-007 | CR 12-052 | CR 12-024 | CR 11-022 | Original Activity ID Rebaseline | EVMS Reporting Codes | BOE Labor | CR 13-015 | Post Rebaseline |
| --- | --- | --- | --- | --- | --- | --- | --- | --- | --- | --- | --- | --- | --- | --- | --- | --- | --- | --- | --- | --- | --- | --- | --- | --- | --- | --- | --- | --- | --- | --- | --- | --- | --- | --- | --- | --- | --- |
|  | 6 | **1.4.2.6 INFRASTRUCTURE** |  |  | 2011-07-01 | 2016-01-28 |  |  |  |  |  |  |  |  |  |  |  |  |  |  |  |  |  |  |  |  |  |  |  |  |  |  |  |  |  |  |  |
|  | 1 | **1.4.2.6.1 UTILITIES** |  |  | 2013-08-30 | 2013-08-30 |  |  |  |  |  |  |  |  |  |  |  |  |  |  |  |  |  |  |  |  |  |  |  |  |  |  |  |  |  |  |  |
| 14261000 |  | Re-Baseline Actuals Adjustment |  | 1d | 2013-08-30 | 2013-08-30 | 9-130M FS+227d | 20d |  |  | PROCUREMENT>$50K 69 NO ESCALATION | 8,812.95 | ELOUADRHIRI L | 1 | 1 | LATIFA E | 13-014 | ADJ |  |  |  |  |  |  |  |  |  |  |  |  |  |  |  |  |  |  |  |
|  | 2 | **1.4.2.6.2 MECHANICAL FRAMES** |  |  |  |  |  |  |  |  |  |  |  |  |  |  |  |  |  |  |  |  |  |  |  |  |  |  |  |  |  |  |  |  |  |  |  |
|  | 3 | **1.4.2.6.3 ASSEMBLY** |  |  | 2013-08-30 | 2013-08-30 |  |  |  |  |  |  |  |  |  |  |  |  |  |  |  |  |  |  |  |  |  |  |  |  |  |  |  |  |  |  |  |
| 14263000 |  | Re-Baseline Actuals Adjustment |  | 1d | 2013-08-30 | 2013-08-30 | 9-130M FS+227d | 20d |  |  | PROCUREMENT>$50K 69 NO ESCALATION | 41.41 | ELOUADRHIRI L | 1 | 1 | LATIFA E | 13-014 | ADJ |  |  |  |  |  |  |  |  |  |  |  |  |  |  |  |  |  |  |  |
|  | 4 | **1.4.2.6.4 INSTALLATION** |  |  | 2011-07-01 | 2016-01-28 |  |  |  |  |  |  |  |  |  |  |  |  |  |  |  |  |  |  |  |  |  |  |  |  |  |  |  |  |  |  |  |
| 14264008a |  | Spaceframe Motion System |  | 122d | 2011-07-01 | 2011-12-30 | 9-110M FS+184d | 985d | 353d |  | PROCUREMENT<$50K 60 NO ESCALATION FY12 | 50,000 | ELOUADRHIRI L | 1 | 1 | LATIFA E |  |  | IN | 08-016 | 09-012 | 09-030 | 09-030 | 11-026 | 11 -035 | 12-051F | 13-002F |  |  |  |  |  |  |  |  |  |  |
| 14264007x |  | Subway Addition Procurement Prep |  | 63d | 2011-07-05 | 2011-09-30 | 9-110M FS+185d | 865d | 233d |  | MECH DES [80 h]; PLANT ENG [160 h] | 14,625.6 | ELOUADRHIRI L | 1 | 1 | LATIFA E |  |  |  |  |  |  |  |  | 11 -035 | 12-051F | 13-002F | 12-027F |  |  |  |  |  |  |  |  |  |
| 14264009 |  | Electrical Utilities Mods of Spaceframe |  | 20d | 2011-08-02 | 2011-08-29 | 9-110M FS+205d | 888d | 256d |  | PROCUREMENT<$50K 60 | 38,000 | ELOUADRHIRI L | 1 | 1 | LATIFA E |  |  | IN | 08-016 | 09-012 | 09-030 | 09-030 | 11-026 | 11 -035 | 12-051F | 13-002F | 12-027F |  |  |  |  |  |  |  |  |  |
| 14264001LOE |  | Installation Procurement Support FY12 |  | 247d | 2011-10-03 | 2012-09-28 | 9-120M | 1010d | 0d |  | MECH TECH [880 h] | 39,107.2 | ELOUADRHIRI L | 1 | 1 | LATIFA E |  |  |  |  |  | 09-030 | 09-030 | 11-026 | 11 -035 |  |  |  |  |  |  |  |  |  |  |  |  |
| 14264000aLOE |  | Installation Engineering Oversight A FY12 |  | 206d | 2011-12-01 | 2012-09-28 | 9-120M FS+41d | 1158d | 0d |  | MECH ENG [1520 h] | 106,582.4 | ELOUADRHIRI L | 1 | 1 | LATIFA E |  |  |  |  |  | 09-030 | 09-030 | 11-026 | 11 -035 |  |  |  | 12-007 |  |  |  |  |  |  |  |  |
| 14264000cLOE |  | Installation Engineering Oversight B FY12 |  | 169d | 2012-02-01 | 2012-09-28 | 9-120M FS+78d | 1158d | 0d |  | MECH ENG [1220 h] | 85,546.4 | ELOUADRHIRI L | 1 | 1 | LATIFA E |  |  |  |  |  | 09-030 | 09-030 | 11-026 | 11 -035 |  |  |  | 12-007 |  |  |  |  |  |  |  |  |
| 14264000 |  | CLAS 6 Removal |  | 181d | 2012-05-14 | 2013-02-06 | 2-02M | 65d | 0d |  |  |  | ELOUADRHIRI L | 1 | 1 | LATIFA E |  |  |  |  |  | 09-030 | 09-030 | 11-026 | 11 -035 |  | 13-002 |  |  |  |  |  |  |  |  |  |  |
| 14264013 |  | Vend Fab Fwd. carriage Mods and install hangers and mount |  | 204d | 2012-06-01 | 2013-03-29 | 14264245 FS-165d, 9-120M FS+163d | 69d | 4d |  | PROCUREMENT<$50K 60 NO ESCALATION FY13 | 40,000 | ELOUADRHIRI L | 1 | 1 | LATIFA E |  |  | IN |  |  | 09-030 | 09-030 | 11-026 | 11 -035 | 12-051 | 13-002 | 12-027 |  |  |  |  |  |  |  |  |  |
| 14264008 |  | Vend Fab Subway Addition with rails and Spaceframe Mod |  | 178d | 2012-09-11 | 2013-05-31 | 9-120M FS+233d, 14264007x, 14264009 | 632d | 0d |  | PROCUREMENT<$50K 60 NO ESCALATION; PROCUREMENT>$50K 69 NO ESCALATION | 277,129 | ELOUADRHIRI L | 1 | 1 | LATIFA E |  |  | IN | 08-016 | 09-012 | 09-030 | 09-030 | 11-026 | 11 -035 | 12-051 | 13-002F | 12-027 |  |  |  |  |  |  |  |  |  |
| 14264000bLOE |  | Installation Engineering Oversight A FY13 |  | 80d | 2012-10-01 | 2013-01-31 | 14264000aLOE | 1158d | 1218d |  | MECH ENG [580 h] | 41,968.8 | ELOUADRHIRI L | 1 | 1 | LATIFA E |  |  |  |  |  | 09-030 | 09-030 | 11-026 | 11 -035 |  |  |  | 12-007 |  |  |  |  |  |  |  |  |
| 14264000dLOE |  | Installation Engineering Oversight B FY13 |  | 80d | 2012-10-01 | 2013-01-31 | 14264000cLOE | 1158d | 1218d |  | MECH ENG [580 h] | 41,968.8 | ELOUADRHIRI L | 1 | 1 | LATIFA E |  |  |  |  |  | 09-030 | 09-030 | 11-026 | 11 -035 |  |  |  | 12-007 |  |  |  |  |  |  |  |  |
| 14264002LOE |  | Installation Procurement Support FY13 |  | 228d | 2012-10-01 | 2013-08-30 | 14264001LOE | 1010d | 1070d |  | MECH TECH [812.31 h] | 37,252.54 | ELOUADRHIRI L | 1 | 1 | LATIFA E | 13-014 |  |  |  |  | 09-030 | 09-030 | 11-026 | 11 -035 |  |  |  |  |  |  |  |  |  |  |  |  |
| 14264362 |  | Vend Fab Fwd. Detector Installation Tooling |  | 184d | 2012-10-01 | 2013-06-28 | 9-130M | 52d | 0d |  | PROCUREMENT<$50K 60 | 39,117.37 | ELOUADRHIRI L | 1 | 1 | LATIFA E |  |  | IN |  |  | 09-030 | 09-030 | 11-026 | 11 -035 |  | 13-002 |  |  | 12-052 |  |  |  |  |  |  |  |
| 14264240 |  | Manufacturing Design of Fwd. Carriage Mods |  | 12d | 2012-12-03 | 2012-12-18 | 9-130M FS+43d | 70d | 0d |  | MECH DES [80 h] | 3,976.8 | ELOUADRHIRI L | 1 | 1 | LATIFA E |  |  | IN |  |  |  |  |  |  |  | 13-002 |  |  | 12-052 |  |  |  |  |  |  |  |
| 14264245 |  | Procurement Prep of Fwd. Carriage Mods |  | 25d | 2012-12-19 | 2013-01-31 | 14264240 | 70d | 1d |  | MECH ENG [8 h] | 578.88 | ELOUADRHIRI L | 1 | 1 | LATIFA E |  |  | IN |  |  |  |  |  |  |  | 13-002 |  |  | 12-052 |  |  |  |  |  |  |  |
| 14264269 |  | Manufacturing Design of Motion System |  | 55d | 2013-01-03 | 2013-03-22 | 9-130M FS+60d | 20d | 0d |  | MECH DES [80 h] | 3,976.8 | ELOUADRHIRI L | 1 | 1 | LATIFA E |  |  | IN |  |  |  |  |  |  |  | 13-002 |  |  | 12-052 |  |  |  |  |  |  |  |
| 14264002M |  | Hall Cleared and Cleaned for CLAS12 installation | milestone | 0d | 2013-02-07 | 2013-02-07 | 2-02M, 2-07M, 14264000 | 65d | 0d |  |  |  | ELOUADRHIRI L | 1 | 1 | LATIFA E |  |  |  |  |  | 09-030 | 09-030 | 11-026 | 11 -035 |  | 13-002 |  |  |  |  |  |  |  |  |  |  |
| 14264238M |  | Start Mods of FWD Carriage | milestone | 0d | 2013-02-07 | 2013-02-07 | 14264002M | 702d | 50d |  |  |  | ELOUADRHIRI L | 1 | 1 | LATIFA E |  |  | IN |  |  |  |  |  |  |  | 13-002 |  |  | 12-052 |  |  |  |  |  |  |  |
| 14264260 |  | Reinforce Fwd Carriage, add motion sysytem mounts and detector mounts |  | 44d | 2013-02-07 | 2013-04-10 | 14264013 FS-40d, 14264002M | 65d | 0d |  | MECH TECH [48 h]; SKLLD TRADE [24 h] | 3,029.76 | ELOUADRHIRI L | 1 | 1 | LATIFA E |  |  | IN |  |  |  |  |  |  |  | 13-002 |  |  | 12-052 |  |  |  |  |  |  |  |
| 14264882 |  | Install DC signal cable trays and gas lines |  | 10d | 2013-02-07 | 2013-02-21 | 14264002M | 129d | 0d |  | PROCUREMENT<$50K 60; PLABOR; MECH TECH [160 h] | 30,826.69 | ELOUADRHIRI L | 1 | 1 | LATIFA E |  |  | IN |  |  | 09-030 | 09-030 | 11-026 | 11 -035 |  | 13-002 |  |  | 12-052 | 12-024 |  |  |  |  |  |  |
| 14264884 |  | Route DC Signal Cables |  | 20d | 2013-02-22 | 2013-03-21 | 14264882 | 129d | 0d |  | PROCUREMENT<$50K 60; PLABOR; MECH TECH [320 h] | 57,011.57 | ELOUADRHIRI L | 1 | 1 | LATIFA E |  |  | IN |  |  | 09-030 | 09-030 | 11-026 | 11 -035 |  | 13-002 |  |  | 12-052 | 12-024 |  |  |  |  |  |  |
| 14264315M |  | Start Installation of Hardware for DAQ | milestone | 0d | 2013-03-01 | 2013-03-01 | 14264002M FS+15d | 118d | 0d |  |  |  | ELOUADRHIRI L | 1 | 1 | LATIFA E |  |  | IN | 08-016 | 09-012 | 09-030 | 09-030 | 11-026 | 11 -035 |  | 13-002 |  |  | 12-052 |  |  |  |  |  |  |  |
| 14264316 |  | Removal of unused cables (DAQ) |  | 10d | 2013-03-01 | 2013-03-14 | 14264315M | 118d | 98d |  | ELEC TECH [160 h] | 7,286.4 | ELOUADRHIRI L | 1 | 1 | LATIFA E |  |  | IN |  |  | 09-030 | 09-030 | 11-026 | 11 -035 |  | 13-002 |  |  | 12-052 |  |  |  |  |  |  |  |
| 14264340M |  | Start Beamline Modifications | milestone | 0d | 2013-03-01 | 2013-03-01 | 14264002M FS+15d | 677d | 0d |  |  |  | ELOUADRHIRI L | 1 | 1 | LATIFA E |  |  | IN |  |  |  |  |  |  |  | 13-002 |  |  | 12-052 |  |  |  |  |  |  |  |
| 14264350 |  | Move Moeller Quads and Table |  | 15d | 2013-03-01 | 2013-03-21 | 14264340M | 677d | 0d |  | MECH TECH [240 h] | 11,006.4 | ELOUADRHIRI L | 1 | 1 | LATIFA E |  |  | IN |  |  |  |  |  |  |  | 13-002 |  |  | 12-052 |  |  |  |  |  |  |  |
| 14264886 |  | Install DC HV/LV Racks and cable trays |  | 6d | 2013-03-21 | 2013-03-28 | 14264884 FS-1d | 129d |  |  | PLABOR; MECH TECH [95.66 h]; PROCUREMENT<$50K 60 | 20,635.46 | ELOUADRHIRI L | 1 | 1 | LATIFA E |  |  | IN |  |  | 09-030 | 09-030 | 11-026 | 11 -035 |  | 13-002 |  |  | 12-052 | 12-024 |  |  |  |  |  |  |
| 14264355 |  | Move GONI |  | 7d | 2013-03-22 | 2013-04-01 | 14264350 | 677d | 0d |  | MECH TECH [80 h] | 3,668.8 | ELOUADRHIRI L | 1 | 1 | LATIFA E |  |  |  |  |  |  |  |  |  |  | 13-002 |  |  | 12-052 |  |  |  |  |  |  |  |
| 14264271 |  | Procurement Prep of Motion System |  | 27d | 2013-03-25 | 2013-04-30 | 14264269 | 20d | 0d |  | MECH ENG [8 h] | 578.88 | ELOUADRHIRI L | 1 | 1 | LATIFA E |  |  | IN |  |  |  |  |  |  |  | 13-002 |  |  | 12-052 |  |  |  |  |  |  |  |
| 14264360 |  | Align Goni and Moeller Quads |  | 3d | 2013-04-02 | 2013-04-04 | 14264355 | 677d | 674d |  | MECH TECH [24 h] | 1,100.64 | ELOUADRHIRI L | 1 | 1 | LATIFA E |  |  |  |  |  |  |  |  |  |  | 13-002 |  |  | 12-052 |  |  |  |  |  |  |  |
| 14264206M |  | ToF Panel 1a - First 3 units Ready for Installation | milestone | 0d | 2013-04-05 | 2013-04-05 | 142232455 | 666d | 78d |  |  |  | ELOUADRHIRI L | 1 | 1 | LATIFA E |  |  |  |  |  |  |  |  |  |  | 13-002 |  |  | 12-052 |  |  |  |  |  |  |  |
| 14264545 |  | Install and wire up Torus PS (G0) |  | 5d | 2013-04-05 | 2013-04-11 | 14264002M FS+40d | 119d |  |  |  |  | ELOUADRHIRI L | 1 | 1 | LATIFA E |  |  |  |  |  |  |  |  |  |  | 13-002 |  |  | 12-052 |  |  |  |  |  |  |  |
| 14264265 |  | Add Hand rails and stairs to FC level 0 |  | 3d | 2013-04-11 | 2013-04-15 | 14264260 | 65d | 0d |  |  |  | ELOUADRHIRI L | 1 | 1 | LATIFA E |  |  | IN |  |  |  |  |  |  |  | 13-002 |  |  | 12-052 |  |  |  |  |  |  |  |
| 14264267 |  | Add AC power to Level 0 FC |  | 3d | 2013-04-16 | 2013-04-18 | 14264265 | 652d | 0d |  |  |  | ELOUADRHIRI L | 1 | 1 | LATIFA E |  |  | IN |  |  |  |  |  |  |  | 13-002 |  |  | 12-052 |  |  |  |  |  |  |  |
| 14264280 |  | Modify LTCC gas piping |  | 15d | 2013-04-19 | 2013-05-09 | 14264267, 14264238M | 652d | 649d |  | MECH TECH [240 h] | 11,006.4 | ELOUADRHIRI L | 1 | 1 | LATIFA E |  |  | IN |  |  |  |  |  |  |  | 13-002 |  |  | 12-052 |  |  |  |  |  |  |  |
| 14264202M |  | R2 Drift Chambers Ready for Installation | milestone | 0d | 2013-05-01 | 2013-05-01 | 142213069 | 106d |  |  |  |  | ELOUADRHIRI L | 1 | 1 | LATIFA E |  |  |  |  |  |  |  |  |  |  | 13-002 |  |  | 12-052 |  |  |  |  |  |  |  |
| 14264273 |  | Vend Fab Motion System |  | 34d | 2013-05-01 | 2013-06-18 | 14264271 | 20d | 0d |  | PROCUREMENT<$50K 60 | 5,763.62 | ELOUADRHIRI L | 1 | 1 | LATIFA E |  |  | IN |  |  |  |  |  |  |  | 13-002 |  |  | 12-052 |  |  |  |  |  |  |  |
| 14264228M |  | Subway Steel Delivered | milestone | 0d | 2013-05-31 | 2013-05-31 | 14264008a, 14264008, 14264002M | 632d | 0d |  |  |  | ELOUADRHIRI L | 1 | 1 | LATIFA E |  |  | IN |  |  |  |  |  |  |  | 13-002 |  |  | 12-052 |  |  |  |  |  |  |  |
| 14264230 |  | Subway Level 1 addition wiring Power Dist. |  | 5d | 2013-06-03 | 2013-06-07 | 14264228M, 14264009 | 632d | 629d |  | PROCUREMENT<$50K 60 | 10,648.18 | ELOUADRHIRI L | 1 | 1 | LATIFA E |  |  | IN |  |  |  |  |  |  |  | 13-002 |  |  | 12-052 |  |  |  |  |  |  |  |
| 14264235 |  | Hall B Control Survey |  | 5d | 2013-06-03 | 2013-06-07 | 14264228M, 14264260, 14264009 | 632d | 629d |  | PROCUREMENT<$50K 60 | 10,648.18 | ELOUADRHIRI L | 1 | 1 | LATIFA E |  |  | IN |  |  |  |  |  |  |  | 13-002 |  |  | 12-052 |  |  |  |  |  |  |  |
| 14264345 |  | Install New Tagger Window |  | 3d | 2013-06-03 | 2013-06-05 | 14264228M, 14264009 | 634d | 631d |  | MECH TECH [72 h] | 3,301.92 | ELOUADRHIRI L | 1 | 1 | LATIFA E |  |  | IN |  |  |  |  |  |  |  | 13-002 |  |  | 12-052 |  |  |  |  |  |  |  |
| 14264278 |  | Install Motion system |  | 5d | 2013-06-19 | 2013-06-25 | 14264265, 14264273 | 20d | 0d |  |  |  | ELOUADRHIRI L | 1 | 1 | LATIFA E |  |  | IN |  |  |  |  |  |  |  | 13-002 |  |  | 12-052 |  |  |  |  |  |  |  |
| 14264220M |  | PCAL - First 5 units Ready for Installation | milestone | 0d | 2013-06-21 | 2013-06-21 | 142223560 | 58d | 6d |  |  |  | ELOUADRHIRI L | 1 | 1 | LATIFA E |  |  |  |  |  |  |  |  |  |  | 13-002 |  |  | 12-052 |  |  |  |  |  |  |  |
| 14264285 |  | Modify Lead nose |  | 4d | 2013-06-26 | 2013-07-01 | 14264278 | 20d | 0d |  | MECH TECH [64 h] | 2,935.04 | ELOUADRHIRI L | 1 | 1 | LATIFA E |  |  |  |  |  |  |  |  |  |  | 13-002 |  |  | 12-052 |  |  |  |  |  |  |  |
| 14264364M |  | Start Installation of FWD Detectors | milestone | 0d | 2013-07-01 | 2013-07-01 | 14264362, 14264260 | 52d | 0d |  |  |  | ELOUADRHIRI L | 1 | 1 | LATIFA E |  |  |  |  |  | 09-030 | 09-030 | 11-026 | 11 -035 |  | 13-002 | 12-027 |  | 12-052 |  | 11-022 |  |  |  |  |  |
| 14264365 |  | Transport and install first 5 sectors PCAL |  | 15d | 2013-07-01 | 2013-07-22 | 14264362, 14264220M, 14264364M | 52d | 0d |  | MECH TECH [400 h]; PLABOR | 28,992.18 | ELOUADRHIRI L | 1 | 1 | LATIFA E |  |  |  |  |  |  |  |  |  |  | 13-002 |  |  | 12-052 |  |  |  |  |  |  |  |
| 14264290 |  | Weld PCAL and LTCC brackets |  | 10d | 2013-07-02 | 2013-07-16 | 14264285 | 20d | 0d |  | PLABOR; MECH TECH [80 h] | 20,757.48 | ELOUADRHIRI L | 1 | 1 | LATIFA E |  |  |  |  |  |  |  |  |  |  | 13-002 |  |  | 12-052 |  |  |  |  |  |  |  |
| 14264375 |  | Cable/test/repair Preshower calorimeters |  | 9d | 2013-07-05 | 2013-07-17 | 14264365 FS-12d | 52d |  |  | MECH TECH [40 h] | 1,834.4 | ELOUADRHIRI L | 1 | 1 | LATIFA E |  |  |  |  |  |  |  |  |  |  | 13-002 |  |  | 12-052 |  |  |  |  |  |  |  |
| 14264295 |  | Install panel 2 TOF brackets |  | 10d | 2013-07-16 | 2013-07-29 | 14264290 FS-1d | 20d | 0d |  | MECH TECH [40 h]; PLABOR | 18,923.08 | ELOUADRHIRI L | 1 | 1 | LATIFA E |  |  |  |  |  |  |  |  |  |  | 13-002 |  |  | 12-052 |  |  |  |  |  |  |  |
| 14264370 |  | Check PCAL positions |  | 3d | 2013-07-23 | 2013-07-25 | 14264365 | 588d | 0d |  | MECH TECH [40 h] | 1,834.4 | ELOUADRHIRI L | 1 | 1 | LATIFA E |  |  |  |  |  |  |  |  |  |  | 13-002 |  |  | 12-052 |  |  |  |  |  |  |  |
| 14264400 |  | Transport and Install ToF 1a - First 3 sectors |  | 6d | 2013-07-26 | 2013-08-02 | 14264370, 14264206M | 588d | 0d |  | MECH TECH [112 h]; PLABOR | 8,543.74 | ELOUADRHIRI L | 1 | 1 | LATIFA E |  |  |  |  |  |  |  |  |  |  | 13-002 |  |  | 12-052 |  |  |  |  |  |  |  |
| 14264297M |  | Start Forward Carriage Precabling | milestone | 0d | 2013-07-30 | 2013-07-30 | 14264295 | 20d | 0d |  |  |  | ELOUADRHIRI L | 1 | 1 | LATIFA E |  |  | IN |  |  |  |  |  |  |  | 13-002 |  |  | 12-052 |  |  |  |  |  |  |  |
| 14264300 |  | Install 10 electronics racks level 0 |  | 3d | 2013-07-30 | 2013-08-01 | 14264297M | 20d | 0d |  | MECH TECH [80 h] | 3,668.8 | ELOUADRHIRI L | 1 | 1 | LATIFA E |  |  |  |  |  |  |  |  |  |  | 13-002 |  |  | 12-052 |  |  |  |  |  |  |  |
| 14264204M |  | R1 Drift Chambers Ready for Installation | milestone | 0d | 2013-08-01 | 2013-08-01 | 142213100 | 42d |  |  |  |  | ELOUADRHIRI L | 1 | 1 | LATIFA E |  |  |  |  |  |  |  |  |  |  | 13-002 |  |  | 12-052 |  |  |  |  |  |  |  |
| 14264305 |  | Install 2 electronics racks level 2 |  | 2d | 2013-08-02 | 2013-08-05 | 14264300 | 20d | 0d |  | MECH TECH [10 h] | 458.6 | ELOUADRHIRI L | 1 | 1 | LATIFA E |  |  |  |  |  |  |  |  |  |  | 13-002 |  |  | 12-052 |  |  |  |  |  |  |  |
| 14264318 |  | Relocate PMT signals/HV/network patch panels |  | 5d | 2013-08-02 | 2013-08-08 | 14264300, 14264316 | 20d | 0d |  | ELEC TECH [80 h] | 3,643.2 | ELOUADRHIRI L | 1 | 1 | LATIFA E |  |  |  |  |  |  |  |  | 11 -035 |  | 13-002 |  |  | 12-052 |  |  |  |  |  |  |  |
| 14264405 |  | Survey (as found location) TOF 1a positions |  | 1d | 2013-08-05 | 2013-08-05 | 14264400 | 588d | 0d |  | MECH TECH [24 h] | 1,100.64 | ELOUADRHIRI L | 1 | 1 | LATIFA E |  |  |  |  |  |  |  |  |  |  | 13-002 |  |  | 12-052 |  |  |  |  |  |  |  |
| 14264308 |  | Reroute EC, CC, TOF HV/signal cables |  | 19d | 2013-08-06 | 2013-08-30 | 14264300 FS-1d, 14264305 | 20d |  |  | MECH TECH [511.54 h] | 23,459.22 | ELOUADRHIRI L | 1 | 1 | LATIFA E | 13-014 |  |  |  |  |  |  |  | 11 -035 |  | 13-002 |  | 12-007 | 12-052 |  |  |  |  |  |  |  |
| 14264410 |  | Cable/test/repair 1a's TOF's |  | 4d | 2013-08-06 | 2013-08-09 | 14264400 FS-4d, 14264405 | 588d | 585d |  | ELEC TECH [24 h] | 1,092.96 | ELOUADRHIRI L | 1 | 1 | LATIFA E |  |  |  |  |  |  |  |  |  |  | 13-002 |  |  | 12-052 |  |  |  |  |  |  |  |
| 14264328 |  | Relocate electronic crates |  | 16d | 2013-08-09 | 2013-08-30 | 14264002M, 14264318 | 20d |  |  | ELEC TECH [256 h] | 11,658.24 | ELOUADRHIRI L | 1 | 1 | LATIFA E | 13-014 |  |  |  |  |  |  |  |  |  | 13-002 |  |  | 12-052 |  |  |  |  |  |  |  |
| 14264998 |  | Re-Baseline Actuals Adjustment |  | 1d | 2013-08-30 | 2013-08-30 | 9-130M FS+227d | 20d |  |  | PROCUREMENT>$50K 69 NO ESCALATION | -190,953.08 | ELOUADRHIRI L | 1 | 1 | LATIFA E | 13-014 | ADJ |  |  |  |  |  |  |  |  |  |  |  |  |  |  |  |  |  |  |  |
| 24264002LOE |  | Installation Procurement Support FY13 |  | 20d | 2013-09-03 | 2013-09-30 | 9-130M FS+228d | 742d | 0d | 8/5 M-F w/JLAB Holidays ReBaseline | MECH ENG [137.58 h] | 9,955.29 | ELOUADRHIRI L | 1 | 1 | LATIFA E |  |  |  |  |  | 09-030 | 09-030 | 11-026 | 11 -035 |  |  |  |  |  |  |  | 24264002LOE | E | PE | 13-015 | PR |
| 24264025M |  | R2 Drift Chambers Ready for Installation | milestone | 0d | 2013-09-03 | 2013-09-03 | 9-130M FS+228d | 530d | 513d | 8/5 M-F w/JLAB Holidays ReBaseline |  |  | ELOUADRHIRI L | 1 | 1 | LATIFA E |  |  |  |  |  |  |  |  |  |  | 13-002 |  |  | 12-052 |  |  | 24264025M | M |  | 13-015 | PR |
| 24264035M |  | ToF Panel 1a - First 3 units Ready for Installation | milestone | 0d | 2013-09-03 | 2013-09-03 | 9-130M FS+228d | 561d | 119d | 8/5 M-F w/JLAB Holidays ReBaseline |  |  | ELOUADRHIRI L | 1 | 1 | LATIFA E |  |  |  |  |  |  |  |  |  |  | 13-002 |  |  | 12-052 |  |  | 24264035M | M |  | 13-015 | PR |

| ID | Activity | Type | Duration | Start | Finish | Predecessors | Total float | Free float | Calendar | Resources | Cost | Original Activity ID Rebaseline | RESP - Responsibility | STRT%COMP for CM EVM | FNSH%COMP for CM EVM | EVMS Reporting Codes | CAM RESPONSIBLE | CR 12-052 | CR 13-002 | CR 13-010 | CR 13-015 | Post Rebaseline | PHAS - Project Phase | BOE Procurement | Over Under Fixed | Obligated Prior to Rebaseline | CR 09-030 | CR 09-030 Repair | CR 11-026 | CR 11-035 | Activities with Steps | BOE Labor | CR 14-001 | Advance Purchase Plan > 500K | CR 08-016 | 12 GEV MAJOR PROCUREMENT CATAGORY | CR 09-012 | CR 12-027 | CR 11-022 | BOE Expenses | CR 12-024 |
| --- | --- | --- | --- | --- | --- | --- | --- | --- | --- | --- | --- | --- | --- | --- | --- | --- | --- | --- | --- | --- | --- | --- | --- | --- | --- | --- | --- | --- | --- | --- | --- | --- | --- | --- | --- | --- | --- | --- | --- | --- | --- |
| 24264045M | ToF Panel 2 Ready for Installation | milestone | 0d | 2013-09-03 | 2013-09-03 | 9-130M FS+228d | 556d | 371d | 8/5 M-F w/JLAB Holidays ReBaseline |  |  | 24264045M | ELOUADRHIRI L | 1 | 1 | M | LATIFA E | 12-052 | 13-002 | 13-010 | 13-015 | PR |  |  |  |  |  |  |  |  |  |  |  |  |  |  |  |  |  |  |  |
| 24264140 | PCAL - Procure PCAL installation stand |  | 40d | 2013-09-03 | 2013-10-28 | 9-130M FS+228d | 446d | 0d | 8/5 M-F w/JLAB Holidays ReBaseline | PROCUREMENT<$50K 60 NO ESCALATION FY14 | 21,969 | 24264140 | ELOUADRHIRI L | 1 | 1 | D | LATIFA E | 12-052 | 13-002 |  | 13-015 | PR | IN | PE |  |  |  |  |  |  |  |  |  |  |  |  |  |  |  |  |  |
| 24264270 | Add AC power to Level 0 FC |  | 22d | 2013-09-03 | 2013-10-02 | 9-130M FS+228d | 476d | 0d | 8/5 M-F w/JLAB Holidays ReBaseline |  |  | 24264270 | ELOUADRHIRI L | 1 | 1 | Z | LATIFA E | 12-052 | 13-002 |  | 13-015 | PR | IN |  |  |  |  |  |  |  |  |  |  |  |  |  |  |  |  |  |  |
| 24264278 | Install Fwd Carriage Mods |  | 20d | 2013-09-03 | 2013-09-30 | 9-130M FS+228d | 304d | 0d | 8/5 M-F w/JLAB Holidays ReBaseline | PROCUREMENT>$50K 69; PROCUREMENT<$50K 60 | 71,953 | 24264278 | ELOUADRHIRI L | 1 | 1 | H | LATIFA E | 12-052 | 13-002 |  | 13-015 | PR | IN | PE | y | OB |  |  |  |  |  |  |  |  |  |  |  |  |  |  |  |
| 24264362 | Vend Fab Fwd. Detector Installation Tooling |  | 40d | 2013-09-03 | 2013-10-28 | 9-130M FS+228d | 446d | 0d | 8/5 M-F w/JLAB Holidays ReBaseline | PROCUREMENT<$50K 60 NO ESCALATION FY14 | 21,069 | 24264362 | ELOUADRHIRI L | 1 | 1 | D | LATIFA E | 12-052 | 13-002 |  | 13-015 | PR | IN | PE |  |  | 09-030 | 09-030 | 11-026 | 11 -035 |  |  |  |  |  |  |  |  |  |  |  |
| 24264517 | Modify Space Frame For Cryo Can |  | 42d | 2013-09-09 | 2013-11-05 | 9-130M FS+232d | 334d | 0d | 8/5 M-F w/JLAB Holidays ReBaseline | PROCUREMENT<$50K 60 NO ESCALATION FY14 | 20,000 | 24264517 | ELOUADRHIRI L | 1 | 1 |  | LATIFA E | 12-052 | 13-002 |  | 13-015 | PR |  | PE |  |  |  |  |  |  |  |  |  |  |  |  |  |  |  |  |  |
| 24264297M | Start Forward Carriage Precabling | milestone | 0d | 2013-09-24 | 2013-09-24 | 24264278 FS-5d | 385d | 0d | 8/5 M-F w/JLAB Holidays ReBaseline |  |  | 24264297M | ELOUADRHIRI L | 1 | 1 | M | LATIFA E | 12-052 | 13-002 |  | 13-015 | PR | IN |  |  |  |  |  |  |  |  |  |  |  |  |  |  |  |  |  |  |
| 24264300 | Precable forward carriage FY13 |  | 5d | 2013-09-24 | 2013-09-30 | 24264297M | 385d | 0d | 8/5 M-F w/JLAB Holidays ReBaseline | ELEC TECH [89.53 h] | 4,077.2 | 24264300 | ELOUADRHIRI L | 1 | 1 | S | LATIFA E | 12-052 | 13-002 |  | 13-015 | PR |  |  |  |  |  |  |  |  | ST | PE |  |  |  |  |  |  |  |  |  |
| 24264003LOE | Installation Enginering Support FY14 |  | 247d | 2013-10-01 | 2014-09-30 | 24264002LOE | 742d | 801d | 8/5 M-F w/JLAB Holidays ReBaseline | MECH ENG [1706 h] | 127,387.02 | 24264003LOE | ELOUADRHIRI L | 1 | 1 | E | LATIFA E |  |  |  | 13-015 | PR |  |  |  |  | 09-030 | 09-030 | 11-026 | 11 -035 |  | PE | 14-001 |  |  |  |  |  |  |  |  |
| 24264300a | Precable forward carriage FY14 |  | 81d | 2013-10-01 | 2014-02-05 | 24264297M, 24264300 | 385d | 0d | 8/5 M-F w/JLAB Holidays ReBaseline | ELEC TECH [1450.47 h] | 68,157.59 | 24264300 | ELOUADRHIRI L | 1 | 1 | S | LATIFA E | 12-052 | 13-002 |  | 13-015 | PR |  |  |  |  |  |  |  |  | ST | PE | 14-001 |  |  |  |  |  |  |  |  |
| 24264515 | Mods to CRYO transfer lines |  | 40d | 2013-10-01 | 2013-11-25 | 9-140M | 339d | 186d | 8/5 M-F w/JLAB Holidays ReBaseline | MECH TECH [320 h] | 15,142.4 | 24264515 | ELOUADRHIRI L | 1 | 1 |  | LATIFA E | 12-052 | 13-002 |  | 13-015 | PR | IN |  |  |  |  |  |  |  |  | PE | 14-001 |  |  |  |  |  |  |  |  |
| 24264935 | Widen the corners of the Hall access walls to allow R3 to pass through horizontal |  | 83d | 2013-10-01 | 2014-02-07 | 9-140M | 427d | 410d | 8/5 M-F w/JLAB Holidays ReBaseline | PROCUREMENT<$50K 60 | 8,255.2 | 24264935 | ELOUADRHIRI L | 1 | 1 | H | LATIFA E | 12-052 | 13-002 |  | 13-015 | PR | IN | EJ |  |  |  | 09-030 | 11-026 | 11 -035 |  |  | 14-001 | APP | 08-016 | 4211 | 09-012 | 12-027 |  |  |  |
| 24264364M | Start Installation of FWD Detectors | milestone | 0d | 2013-10-29 | 2013-10-29 | 24264278, 24264362, 24264140 | 446d | 61d | 8/5 M-F w/JLAB Holidays ReBaseline |  |  | 24264364M | ELOUADRHIRI L | 1 | 1 | M | LATIFA E | 12-052 | 13-002 |  | 13-015 | PR |  |  |  |  | 09-030 | 09-030 | 11-026 | 11 -035 |  |  |  |  |  |  |  | 12-027 | 11-022 |  |  |
| 24264395 | Cable/test/repair EC |  | 85d | 2013-10-29 | 2014-03-11 | 24264365 FS-142d, 9-140M FS+20d | 446d | 443d | 8/5 M-F w/JLAB Holidays ReBaseline | SCIENTIST [96 h]; MECH TECH [192 h] | 16,302.72 | 24264395 | ELOUADRHIRI L | 1 | 1 | S | LATIFA E | 12-052 | 13-002 |  | 13-015 | PR |  |  |  |  |  |  |  |  | ST | PE | 14-001 |  |  |  |  |  |  |  |  |
| 24264520 | Modify Space Frame Level 3 deck For Torus Cryo |  | 20d | 2013-11-06 | 2013-12-05 | 24264517 | 334d | 181d | 8/5 M-F w/JLAB Holidays ReBaseline | MECH TECH [80 h] | 3,785.6 | 24264520 | ELOUADRHIRI L | 1 | 1 |  | LATIFA E | 12-052 | 13-002 |  | 13-015 | PR |  |  |  |  |  |  |  |  |  | PE | 14-001 |  |  |  |  |  |  |  |  |
| 24264280 | Modify LTCC gas piping |  | 43d | 2013-11-13 | 2014-01-27 | 24264270 FS+29d | 476d | 0d | 8/5 M-F w/JLAB Holidays ReBaseline | MECH DES [240 h]; MECH TECH [480 h] | 35,025.6 | 24264280 | ELOUADRHIRI L | 1 | 1 | S | LATIFA E | 12-052 | 13-002 |  | 13-015 | PR | IN |  |  |  |  |  |  |  | ST | PE | 14-001 |  |  |  |  |  |  |  |  |
| 24264890 | DC - design mounts and adjusters for DC to Torus |  | 82d | 2013-12-05 | 2014-04-10 | 9-140M FS+45d | 226d | 0d | 8/5 M-F w/JLAB Holidays ReBaseline | PLABOR | 25,756.22 | 24264890 | ELOUADRHIRI L | 1 | 1 | S | LATIFA E | 12-052 | 13-002 |  | 13-015 | PR | IN |  |  |  |  | 09-030 | 11-026 | 11 -035 | ST |  | 14-001 | APP | 08-016 | 4211 | 09-012 | 12-027 |  | PE |  |
| 24264050M | ToF Panel 1b - First 3 units Ready for Installation | milestone | 0d | 2014-01-02 | 2014-01-02 | 242232320R, 242232320S | 456d | 71d | 8/5 M-F w/JLAB Holidays ReBaseline |  |  | 24264050M | ELOUADRHIRI L | 1 | 1 | M | LATIFA E | 12-052 | 13-002 |  | 13-015 | PR |  |  |  |  |  |  |  |  |  |  |  |  |  |  |  |  |  |  |  |
| 24264055M | ToF Panel 1b - Last 3 units Ready for Installation | milestone | 0d | 2014-01-02 | 2014-01-02 | 242232320S, 242232320R | 470d | 285d | 8/5 M-F w/JLAB Holidays ReBaseline |  |  | 24264055M | ELOUADRHIRI L | 1 | 1 | M | LATIFA E | 12-052 | 13-002 |  | 13-015 | PR |  |  |  |  |  |  |  |  |  |  |  |  |  |  |  |  |  |  |  |
| 24264888 | Reroute DC gas lines to the distribution pannel |  | 134d | 2014-01-06 | 2014-07-15 | 9-140M FS+59d | 358d | 355d | 8/5 M-F w/JLAB Holidays ReBaseline | MECH TECH [240 h] | 11,356.8 | 24264888 | ELOUADRHIRI L | 1 | 1 | S | LATIFA E | 12-052 | 13-002 |  | 13-015 | PR | IN |  |  |  | 09-030 | 09-030 | 11-026 | 11 -035 | ST | PE | 14-001 |  |  |  |  |  |  |  | 12-024 |
| 24264281 | Install new gas lines from gas sched to the hall |  | 10d | 2014-01-14 | 2014-01-28 | 24264280 FS-9d | 476d | 473d | 8/5 M-F w/JLAB Holidays ReBaseline | MECH TECH [280 h] | 13,249.6 | 24264281 | ELOUADRHIRI L | 1 | 1 | S | LATIFA E | 12-052 | 13-002 |  | 13-015 | PR | IN |  |  |  |  |  |  |  | ST | PE | 14-001 |  |  |  |  |  |  |  |  |
| 24264895 | DC - mounts and adjusters Engineering Analysis |  | 37d | 2014-01-16 | 2014-03-10 | 24264890 FS-60d | 249d | 59d | 8/5 M-F w/JLAB Holidays ReBaseline | MECH ENG [240 h] | 17,920.8 | 24264895 | ELOUADRHIRI L | 1 | 1 | S | LATIFA E | 12-052 | 13-002 |  | 13-015 | PR | IN |  |  |  |  | 09-030 | 11-026 | 11 -035 | ST | PE | 14-001 | APP | 08-016 | 4211 | 09-012 | 12-027 |  |  |  |
| 24264365 | Transport and install PCAL |  | 15d | 2014-02-06 | 2014-02-26 | 242223563M, 24264300a, 24264364M, 24264140, 24264362, 24264300 | 385d | 0d | 8/5 M-F w/JLAB Holidays ReBaseline | MECH TECH [480 h] | 22,713.6 | 24264365 | ELOUADRHIRI L | 1 | 1 | S | LATIFA E | 12-052 | 13-002 |  | 13-015 | PR |  |  |  |  |  |  |  |  | ST | PE | 14-001 |  |  |  |  |  |  |  |  |
| 24264390 | Cable/test/repair Preshower calorimeters |  | 20d | 2014-02-10 | 2014-03-07 | 24264365 FS-13d | 448d | 445d | 8/5 M-F w/JLAB Holidays ReBaseline | SCIENTIST [72 h]; MECH TECH [72 h] | 8,820 | 24264390 | ELOUADRHIRI L | 1 | 1 | H | LATIFA E | 12-052 | 13-002 |  | 13-015 | PR |  |  |  |  |  |  |  |  |  | PE | 14-001 |  |  |  |  |  |  |  |  |
| 24264370 | Check PCAL positions |  | 2d | 2014-02-27 | 2014-02-28 | 24264365 | 442d | 0d | 8/5 M-F w/JLAB Holidays ReBaseline | MECH TECH [48 h] | 2,271.36 | 24264370 | ELOUADRHIRI L | 1 | 1 | H | LATIFA E | 12-052 | 13-002 |  | 13-015 | PR |  |  |  |  |  |  |  |  |  | PE | 14-001 |  |  |  |  |  |  |  |  |
| 24264400 | Transport and Install ToF 1a |  | 11d | 2014-03-04 | 2014-03-18 | 24264370 FS+1d, 24264035M | 442d | 0d | 8/5 M-F w/JLAB Holidays ReBaseline | MECH TECH [384 h] | 18,170.88 | 24264400 | ELOUADRHIRI L | 1 | 1 | S | LATIFA E | 12-052 | 13-002 |  | 13-015 | PR |  |  |  |  |  |  |  |  | ST | PE | 14-001 |  |  |  |  |  |  |  |  |
| 24264410 | Cable/test/repair 1a's TOF's |  | 9d | 2014-03-05 | 2014-03-17 | 24264405 FS-13d, 24264400 FS-10d | 442d | 439d | 8/5 M-F w/JLAB Holidays ReBaseline | MECH TECH [144 h]; SCIENTIST [72 h] | 12,227.04 | 24264410 | ELOUADRHIRI L | 1 | 1 | S | LATIFA E | 12-052 | 13-002 |  | 13-015 | PR |  |  |  |  |  |  |  |  | ST | PE | 14-001 |  |  |  |  |  |  |  |  |
| 24264790 | Solenoid - design adjustment system for solenoid and HTCC rails |  | 25d | 2014-03-05 | 2014-04-08 | 9-140M FS+100d | 177d | 0d | 8/5 M-F w/JLAB Holidays ReBaseline | MECH DES [200 h] | 10,260 | 24264790 | ELOUADRHIRI L | 1 | 1 | H | LATIFA E | 12-052 | 13-002 |  | 13-015 | PR | IN |  |  |  | 09-030 | 09-030 | 11-026 | 11 -035 |  | PE | 14-001 |  |  |  |  |  |  |  |  |
| 24264405 | Survey (as found location) TOF 1a positions |  | 2d | 2014-03-20 | 2014-03-21 | 24264400 FS+1d | 442d | 0d | 8/5 M-F w/JLAB Holidays ReBaseline | MECH TECH [72 h] | 3,407.04 | 24264405 | ELOUADRHIRI L | 1 | 1 | H | LATIFA E | 12-052 | 13-002 |  | 13-015 | PR |  |  |  |  |  |  |  |  |  | PE | 14-001 |  |  |  |  |  |  |  |  |
| 24264105 | SVT - Design mounts for SVT to solenoid cart |  | 39d | 2014-04-02 | 2014-05-27 | 9-140M FS+120d | 252d | 0d | 8/5 M-F w/JLAB Holidays ReBaseline | MECH DES [160 h] | 8,208 | 24264105 | ELOUADRHIRI L | 1 | 1 | H | LATIFA E | 12-052 | 13-002 |  | 13-015 | PR | IN |  |  |  |  |  |  |  |  | PE | 14-001 |  |  |  |  |  |  |  |  |
| 24264793 | Solenoid - design motion system |  | 24d | 2014-04-09 | 2014-05-12 | 24264790 | 213d | 0d | 8/5 M-F w/JLAB Holidays ReBaseline | MECH DES [200 h] | 10,260 | 24264793 | ELOUADRHIRI L | 1 | 1 | H | LATIFA E | 12-052 | 13-002 |  | 13-015 | PR | IN |  |  |  | 09-030 | 09-030 | 11-026 | 11 -035 |  | PE | 14-001 |  |  |  |  |  |  |  |  |
| 24264795 | Solenoid - design cart |  | 24d | 2014-04-09 | 2014-05-12 | 24264790 | 177d | 0d | 8/5 M-F w/JLAB Holidays ReBaseline | PLABOR | 12,878.11 | 24264795 | ELOUADRHIRI L | 1 | 1 | S | LATIFA E | 12-052 | 13-002 |  | 13-015 | PR | IN |  |  |  | 09-030 | 09-030 | 11-026 | 11 -035 | ST |  | 14-001 |  |  |  |  |  |  | PE |  |
| 24264905 | DC - design cable trays and gas system mounts |  | 127d | 2014-04-11 | 2014-10-09 | 9-140M FS+127d | 49d | 0d | 8/5 M-F w/JLAB Holidays ReBaseline | PLABOR | 30,048.93 | 24264905 | ELOUADRHIRI L | 1 | 1 | S | LATIFA E | 12-052 | 13-002 |  | 13-015 | PR | IN |  |  |  |  | 09-030 | 11-026 | 11 -035 | ST |  | 14-001 | APP | 08-016 | 4211 | 09-012 | 12-027 |  | PE |  |
| 24264430 | Transport and install ToF 1b |  | 12d | 2014-04-14 | 2014-04-29 | 24264050M, 24264365 FS+32d | 385d | 0d | 8/5 M-F w/JLAB Holidays ReBaseline | MECH TECH [384 h] | 18,170.88 | 24264430 | ELOUADRHIRI L | 1 | 1 | S | LATIFA E | 12-052 | 13-002 |  | 13-015 | PR |  |  |  |  |  |  |  |  | ST | PE | 14-001 |  |  |  |  |  |  |  |  |
| 24264796 | Solenoid - cart Engineering Analysis |  | 22d | 2014-04-29 | 2014-05-29 | 24264795 FS-10d | 177d | 2d | 8/5 M-F w/JLAB Holidays ReBaseline | MECH ENG [160 h] | 11,947.2 | 24264796 | ELOUADRHIRI L | 1 | 1 | S | LATIFA E | 12-052 | 13-002 |  | 13-015 | PR | IN |  |  |  | 09-030 | 09-030 | 11-026 | 11 -035 | ST | PE | 14-001 |  |  |  |  |  |  |  |  |
| 24264435 | Survey (as found location) TOF 1b's |  | 2d | 2014-04-30 | 2014-05-01 | 24264430 | 385d | 200d | 8/5 M-F w/JLAB Holidays ReBaseline | MECH TECH [72 h] | 3,407.04 | 24264435 | ELOUADRHIRI L | 1 | 1 | H | LATIFA E | 12-052 | 13-002 |  | 13-015 | PR |  |  |  |  |  |  |  |  |  | PE | 14-001 |  |  |  |  |  |  |  |  |
| 24264440 | Cable/test/repair 1b's TOF's |  | 10d | 2014-04-30 | 2014-05-13 | 24264430 | 401d | 398d | 8/5 M-F w/JLAB Holidays ReBaseline | MECH TECH [144 h]; SCIENTIST [72 h] | 12,227.04 | 24264440 | ELOUADRHIRI L | 1 | 1 | S | LATIFA E | 12-052 | 13-002 |  | 13-015 | PR |  |  |  |  |  |  |  |  | ST | PE | 14-001 |  |  |  |  |  |  |  |  |
| 24264030M | R1 Drift Chambers Ready for Installation | milestone | 0d | 2014-05-01 | 2014-05-01 | 242213100 | 384d | 367d | 8/5 M-F w/JLAB Holidays ReBaseline |  |  | 24264030M | ELOUADRHIRI L | 1 | 1 | M | LATIFA E | 12-052 | 13-002 |  | 13-015 | PR |  |  |  |  |  |  |  |  |  |  |  |  |  |  |  |  |  |  |  |
| 24264791 | Solenoid - procure rails and adjustment components for solenoid and HTCC rails |  | 63d | 2014-05-06 | 2014-08-04 | 24264790 FS+19d | 177d | 0d | 8/5 M-F w/JLAB Holidays ReBaseline | PROCUREMENT<$50K 60 | 22,783.32 | 24264791 | ELOUADRHIRI L | 1 | 1 | D | LATIFA E | 12-052 | 13-002 |  | 13-015 | PR | IN | PE |  |  | 09-030 | 09-030 | 11-026 | 11 -035 |  |  | 14-001 |  |  |  |  |  |  |  |  |
| 24264794 | Solenoid - procure motion system |  | 42d | 2014-05-06 | 2014-07-03 | 24264793 FS-5d | 213d | 36d | 8/5 M-F w/JLAB Holidays ReBaseline | PROCUREMENT<$50K 60 | 3,579.66 | 24264794 | ELOUADRHIRI L | 1 | 1 | D | LATIFA E | 12-052 | 13-002 |  | 13-015 | PR | IN | PE |  |  | 09-030 | 09-030 | 11-026 | 11 -035 |  |  | 14-001 |  |  |  |  |  |  |  |  |
| 24264545 | Install and wire up Torus PS (G0) |  | 5d | 2014-05-07 | 2014-05-13 | 9-140M FS+145d | 82d | 32d | 8/5 M-F w/JLAB Holidays ReBaseline | ELEC TECH [160 h] | 7,518.4 | 24264545 | ELOUADRHIRI L | 1 | 1 |  | LATIFA E | 12-052 | 13-002 |  | 13-015 | PR |  |  |  |  |  |  |  |  |  | PE | 14-001 |  |  |  |  |  |  |  |  |
| 24264110 | SVT - Design Insertion/service cart and installation arm |  | 39d | 2014-05-28 | 2014-07-22 | 24264105 | 252d | 0d | 8/5 M-F w/JLAB Holidays ReBaseline | MECH DES [200 h] | 10,260 | 24264110 | ELOUADRHIRI L | 1 | 1 | H | LATIFA E | 12-052 | 13-002 |  | 13-015 | PR | IN |  |  |  |  |  |  |  |  | PE | 14-001 |  |  |  |  |  |  |  |  |
| 24264797 | Solenoid - procure cart |  | 64d | 2014-06-03 | 2014-09-02 | 24264796, 9-140M FS+163d | 175d | 84d | 8/5 M-F w/JLAB Holidays ReBaseline | PROCUREMENT<$50K 60 | 54,761.9 | 24264797 | ELOUADRHIRI L | 1 | 1 | D | LATIFA E | 12-052 | 13-002 |  | 13-015 | PR | IN | PE |  |  | 09-030 | 09-030 | 11-026 | 11 -035 |  |  | 14-001 |  |  |  |  |  |  |  |  |
| 24264900 | DC - procure mounts and adjusters for DC to Torus |  | 84d | 2014-06-03 | 2014-09-30 | 24264895, 9-140M FS+163d, 24264890 | 190d | 173d | 8/5 M-F w/JLAB Holidays ReBaseline | PROCUREMENT<$50K 60 | 78,000.29 | 24264900 | ELOUADRHIRI L | 1 | 1 | D | LATIFA E | 12-052 | 13-002 |  | 13-015 | PR | IN | PE |  |  |  | 09-030 | 11-026 | 11 -035 |  |  | 14-001 | APP | 08-016 | 4211 | 09-012 | 12-027 |  |  |  |
| 24264282 | Design modifications to Lead Nose |  | 15d | 2014-06-05 | 2014-06-25 | 9-140M FS+165d | 330d | 0d | 8/5 M-F w/JLAB Holidays ReBaseline | PLABOR | 6,439.06 | 24264282 | ELOUADRHIRI L | 1 | 1 | H | LATIFA E | 12-052 | 13-002 |  | 13-015 | PR | IN |  |  |  |  |  |  |  |  |  | 14-001 |  |  |  |  |  |  | PE |  |
| 24264285 | Modify Lead nose |  | 13d | 2014-06-26 | 2014-07-15 | 24264278, 24264282 | 330d | 145d | 8/5 M-F w/JLAB Holidays ReBaseline | MECH TECH [64 h] | 3,028.48 | 24264285 | ELOUADRHIRI L | 1 | 1 | H | LATIFA E | 12-052 | 13-002 |  | 13-015 | PR |  |  |  |  |  |  |  |  |  | PE | 14-001 |  |  |  |  |  |  |  |  |
| 24264085M | First Torus Cryostat Ready | milestone | 0d | 2014-06-30 | 2014-06-30 | 242743005 | 50d | 0d | 8/5 M-F w/JLAB Holidays ReBaseline |  |  | 24264085M | ELOUADRHIRI L | 1 | 1 | M | LATIFA E | 12-052 | 13-002 |  | 13-015 | PR |  |  |  |  |  |  |  |  |  |  |  |  |  |  |  |  |  |  |  |
| 24264548M | Start Torus Installation | milestone | 0d | 2014-06-30 | 2014-06-30 | 24264545, 242751240, 242751415, 242751250, 24264085M | 50d | 6d | 8/5 M-F w/JLAB Holidays ReBaseline |  |  | 24264548M | ELOUADRHIRI L | 1 | 1 | M | LATIFA E | 12-052 | 13-002 |  | 13-015 | PR | IN |  |  |  |  |  |  |  |  |  |  |  |  |  |  |  |  |  |  |
| 24264565 | Attach cold hub to Coil D |  | 7d | 2014-07-09 | 2014-07-17 | 242751290, 242742075, 242751180, 24264548M, 24264085M | 44d | 0d | 8/5 M-F w/JLAB Holidays ReBaseline | MECH TECH [224 h] | 10,599.68 | 24264565 | ELOUADRHIRI L | 1 | 1 |  | LATIFA E | 12-052 | 13-002 |  | 13-015 | PR |  |  |  |  |  |  |  |  |  | PE | 14-001 |  |  |  |  |  |  |  |  |
| 24264570 | Attach Center Base Legs to Coil D |  | 7d | 2014-07-18 | 2014-07-28 | 24264565 | 44d | 0d | 8/5 M-F w/JLAB Holidays ReBaseline | MECH TECH [224 h] | 10,599.68 | 24264570 | ELOUADRHIRI L | 1 | 1 |  | LATIFA E | 12-052 | 13-002 |  | 13-015 | PR |  |  |  |  |  |  |  |  |  | PE | 14-001 |  |  |  |  |  |  |  |  |
| 24264115 | SVT - Design transportation cart/skid |  | 52d | 2014-07-23 | 2014-10-03 | 24264110 | 252d | 0d | 8/5 M-F w/JLAB Holidays ReBaseline | MECH DES [480 h] | 24,624 | 24264115 | ELOUADRHIRI L | 1 | 1 | S | LATIFA E | 12-052 | 13-002 |  | 13-015 | PR | IN |  |  |  |  |  |  |  | ST | PE | 14-001 |  |  |  |  |  |  |  |  |
| 24264575 | Install Temporary Braces to Hall Floor for Coil D and Beam left and right Cold Rings |  | 10d | 2014-07-29 | 2014-08-11 | 24264570 | 44d | 19d | 8/5 M-F w/JLAB Holidays ReBaseline | MECH TECH [480 h]; MECH ENG [40 h]; MECH DES [40 h] | 27,752.4 | 24264575 | ELOUADRHIRI L | 1 | 1 |  | LATIFA E | 12-052 | 13-002 |  | 13-015 | PR |  |  |  |  |  |  |  |  |  | PE | 14-001 |  |  |  |  |  |  |  |  |
| 24264910 | DC - cable trays and gas system mounts Engineering Analysis |  | 23d | 2014-08-01 | 2014-09-03 | 24264905 FS-49d | 74d | 25d | 8/5 M-F w/JLAB Holidays ReBaseline | MECH ENG [200 h] | 14,934 | 24264910 | ELOUADRHIRI L | 1 | 1 | S | LATIFA E | 12-052 | 13-002 |  | 13-015 | PR | IN |  |  |  |  | 09-030 | 11-026 | 11 -035 | ST | PE | 14-001 | APP | 08-016 | 4211 | 09-012 | 12-027 |  |  |  |
| 24264792 | Solenoid - Install and Align rails and adjustment components for solenoid and HTCC rails |  | 15d | 2014-08-05 | 2014-08-25 | 24264791 | 177d | 0d | 8/5 M-F w/JLAB Holidays ReBaseline | MECH TECH |  | 24264792 | ELOUADRHIRI L | 1 | 1 | Z | LATIFA E | 12-052 | 13-002 |  | 13-015 | PR | IN |  |  |  | 09-030 | 09-030 | 11-026 | 11 -035 |  | PE |  |  |  |  |  |  |  |  |  |
| 24264794a | Solenoid - Install motion system |  | 5d | 2014-08-26 | 2014-09-02 | 24264792, 24264794 | 177d | 84d | 8/5 M-F w/JLAB Holidays ReBaseline | MECH TECH [80 h] | 3,785.6 | 24264794a | ELOUADRHIRI L | 1 | 1 | H | LATIFA E | 12-052 | 13-002 |  | 13-015 | PR | IN |  |  |  | 09-030 | 09-030 | 11-026 | 11 -035 |  | PE | 14-001 |  |  |  |  |  |  |  |  |
| 24264120 | SVT - Cart/Skid Engineering analysis |  | 12d | 2014-08-27 | 2014-09-12 | 24264110 FS+25d | 267d | 15d | 8/5 M-F w/JLAB Holidays ReBaseline | MECH ENG [240 h] | 17,920.8 | 24264120 | ELOUADRHIRI L | 1 | 1 | S | LATIFA E | 12-052 | 13-002 |  | 13-015 | PR | IN |  |  |  |  |  |  |  | ST | PE | 14-001 |  |  |  |  |  |  |  |  |
| 24264525 | Distribution Can - Transport and position distribution box |  | 2d | 2014-09-02 | 2014-09-03 | 24264515, 242761030, 24264520 FS-1d | 153d | 0d | 8/5 M-F w/JLAB Holidays ReBaseline | MECH TECH [64 h] | 3,028.48 | 24264525 | ELOUADRHIRI L | 1 | 1 |  | LATIFA E | 12-052 | 13-002 |  | 13-015 | PR |  |  |  |  |  |  |  |  |  | PE | 14-001 |  |  |  |  |  |  |  |  |
| 24264550 | Install 3 Torus Base support and adjustment Stands |  | 5d | 2014-09-02 | 2014-09-08 | 24264548M FS-10d, 242751440, 242751385 | 25d | 0d | 8/5 M-F w/JLAB Holidays ReBaseline | MECH DES [20 h]; MECH ENG [20 h]; MECH TECH [160 h] | 10,090.6 | 24264550 | ELOUADRHIRI L | 1 | 1 |  | LATIFA E | 12-052 | 13-002 |  | 13-015 | PR |  |  |  |  |  |  |  |  |  | PE | 14-001 |  |  |  |  |  |  |  |  |
| 24264230 | Subway Level 1 addition wiring Power Dist. |  | 5d | 2014-09-04 | 2014-09-10 | 9-140M FS+228d | 190d | 133d | 8/5 M-F w/JLAB Holidays ReBaseline | PROCUREMENT<$50K 60 | 10,987.86 | 24264230 | ELOUADRHIRI L | 1 | 1 | S | LATIFA E | 12-052 | 13-002 |  | 13-015 | PR | IN | PE |  |  |  |  |  |  | ST |  | 14-001 |  |  |  |  |  |  |  |  |
| 24264527 | Distribution Can - Connect cold piping with fittings and welding |  | 5d | 2014-09-04 | 2014-09-10 | 24264525 | 153d | 0d | 8/5 M-F w/JLAB Holidays ReBaseline | MECH TECH [160 h] | 7,571.2 | 24264525 | ELOUADRHIRI L | 1 | 1 |  | LATIFA E | 12-052 | 13-002 |  | 13-015 | PR |  |  |  |  |  |  |  |  |  | PE | 14-001 |  |  |  |  |  |  |  |  |
| 24264580 | Install Coil D Assembly |  | 7d | 2014-09-09 | 2014-09-17 | 24264550, 24264575 | 25d | 0d | 8/5 M-F w/JLAB Holidays ReBaseline | MECH TECH [336 h]; MECH ENG [56 h] | 20,081.04 | 24264580 | ELOUADRHIRI L | 1 | 1 |  | LATIFA E | 12-052 | 13-002 |  | 13-015 | PR |  |  |  |  |  |  |  |  |  | PE | 14-001 |  |  |  |  |  |  |  |  |
| 24264529 | Distribution Can - Connect Instrumentation and valves |  | 5d | 2014-09-11 | 2014-09-17 | 24264527 | 153d | 0d | 8/5 M-F w/JLAB Holidays ReBaseline | MECH TECH [160 h] | 7,571.2 | 24264525 | ELOUADRHIRI L | 1 | 1 |  | LATIFA E | 12-052 | 13-002 |  | 13-015 | PR |  |  |  |  |  |  |  |  |  | PE | 14-001 |  |  |  |  |  |  |  |  |
| 24264531 | Distribution Can - leak test system |  | 4d | 2014-09-18 | 2014-09-23 | 24264529 | 153d | 0d | 8/5 M-F w/JLAB Holidays ReBaseline | MECH TECH [128 h] | 6,056.96 | 24264525 | ELOUADRHIRI L | 1 | 1 |  | LATIFA E | 12-052 | 13-002 |  | 13-015 | PR |  |  |  |  |  |  |  |  |  | PE | 14-001 |  |  |  |  |  |  |  |  |
| 24264585 | Install Beam left and right cold ring beams |  | 10d | 2014-09-18 | 2014-10-01 | 24264580 | 25d | 0d | 8/5 M-F w/JLAB Holidays ReBaseline | MECH TECH [320 h] | 15,142.4 | 24264585 | ELOUADRHIRI L | 1 | 1 |  | LATIFA E | 12-052 | 13-002 |  | 13-015 | PR |  |  |  |  |  |  |  |  |  | PE | 14-001 |  |  |  |  |  |  |  |  |
| 24264533 | Distribution Can - pressure test system |  | 2d | 2014-09-24 | 2014-09-25 | 24264531 | 153d | 0d | 8/5 M-F w/JLAB Holidays ReBaseline | MECH TECH [64 h] | 3,028.48 | 24264525 | ELOUADRHIRI L | 1 | 1 |  | LATIFA E | 12-052 | 13-002 |  | 13-015 | PR |  |  |  |  |  |  |  |  |  | PE | 14-001 |  |  |  |  |  |  |  |  |
| 24264535 | Distribution Can - final leak test system |  | 3d | 2014-09-26 | 2014-09-30 | 24264533 | 153d | 0d | 8/5 M-F w/JLAB Holidays ReBaseline | MECH TECH [96 h] | 4,542.72 | 24264525 | ELOUADRHIRI L | 1 | 1 |  | LATIFA E | 12-052 | 13-002 |  | 13-015 | PR |  |  |  |  |  |  |  |  |  | PE | 14-001 |  |  |  |  |  |  |  |  |
| 24264005LOE | Installation Engineering Oversight FY15 |  | 246d | 2014-09-30 | 2015-09-29 | 242751010LOE FS-16d | 420d | 0d | 8/5 M-F w/JLAB Holidays ReBaseline | SR STAFF [2712 h]; MECH ENG [1699.2 h] | 453,187.1 | 24264005LOE | ELOUADRHIRI L | 1 | 1 | E | LATIFA E |  |  |  | 13-015 | PR |  |  |  |  | 09-030 | 09-030 | 11-026 | 11 -035 |  | PE | 14-001 |  |  |  |  |  |  |  |  |
| 24264090M | Last Torus Cryostat Ready | milestone | 0d | 2014-10-01 | 2014-10-01 | 2-34M | 72d | 55d | 8/5 M-F w/JLAB Holidays ReBaseline |  |  | 24264090M | ELOUADRHIRI L | 1 | 1 | M | LATIFA E | 12-052 | 13-002 |  | 13-015 | PR |  |  |  |  |  |  |  |  |  |  |  |  |  |  |  |  |  |  |  |
| 24264145 | HTCC - design transport cart |  | 56d | 2014-10-01 | 2014-12-19 | 9-155M | 194d | 0d | 8/5 M-F w/JLAB Holidays ReBaseline | PLABOR; MECH ENG [40 h] | 18,011.26 | 24264145 | ELOUADRHIRI L | 1 | 1 | S | LATIFA E | 12-052 | 13-002 |  | 13-015 | PR | IN |  |  |  |  |  |  |  | ST | PE | 14-001 |  |  |  |  |  |  | PE |  |
| 24264345 | Install New Tagger Window |  | 3d | 2014-10-01 | 2014-10-03 | 9-155M | 301d | 298d | 8/5 M-F w/JLAB Holidays ReBaseline | MECH TECH [72 h] | 3,407.04 | 24264345 | ELOUADRHIRI L | 1 | 1 | H | LATIFA E | 12-052 | 13-002 |  | 13-015 | PR | IN |  |  |  |  |  |  |  |  | PE | 14-001 |  |  |  |  |  |  |  |  |

Notes:
- 24264300: Steps: Cable Sector 5; Cable Sector 6; Cable Sector 1; Cable Sector 2; Cable Sector 3; Cable Sector 4
- 24264300a: Steps: Cable Sector 5; Cable Sector 6; Cable Sector 1; Cable Sector 2; Cable Sector 3; Cable Sector 4
- 24264395: Steps: Cable/test/repair EC sector 1; Cable/test/repair EC sector 2; Cable/test/repair EC sector 3; Cable/test/repair EC sector 4; Cable/test/repair EC sector 5; Cable/test/repair EC sector 6
- 24264280: Steps: Design gas piping system; Install piping for sector 1; Install piping for sector 2; Install piping for sector 3; Install piping for sector 4; Install piping for sector 5; Install piping for sector 6
- 24264890: Steps: DC - design mounts and adjusters for DC to Torus for region 1; DC - design mounts and adjusters for DC to Torus for region 2; DC - design mounts and adjusters for DC to Torus for region 3
- 24264888: Steps: Route gas lines for region 1; Route gas lines for region 2; Route gas lines for region 3
- 24264281: Steps: Install supply piping; Install return piping
- 24264895: Steps: Hand Calculations; FEA Analysis; Report
- 24264365: Steps: Transport and install sector 1; Transport and install sector 2; Transport and install sector 3; Transport and install sector 4; Transport and install sector 5; Transport and install sector 6
- 24264400: Steps: Transport and Install ToF 1a Sector 1; Transport and Install ToF 1a Sector 2; Transport and Install ToF 1a Sector 3; Transport and Install ToF 1a Sector 4; Transport and Install ToF 1a Sector 5; Transport and Install ToF 1a Sector 6
- 24264410: Steps: Cable/test/repair 1a's TOF's sector 1; Cable/test/repair 1a's TOF's sector 2; Cable/test/repair 1a's TOF's sector 3; Cable/test/repair 1a's TOF's sector 4; Cable/test/repair 1a's TOF's sector 5; Cable/test/repair 1a's TOF's sector 6
- 24264795: Steps: Conceptual design; 3D model; Drawings
- 24264905: Steps: Conceptual design; 3D model; Drawings
- 24264430: Steps: Transport and install ToF 1b Sector 1; Transport and install ToF 1b Sector 2; Transport and install ToF 1b Sector 3; Transport and install ToF 1b Sector 4; Transport and install ToF 1b Sector 5; Transport and install ToF 1b Sector 6
- 24264796: Steps: Hand Calculations; FEA Analysis; Report
- 24264440: Steps: Cable/test/repair 1b's TOF's Sector 1; Cable/test/repair 1b's TOF's Sector 2; Cable/test/repair 1b's TOF's Sector 3; Cable/test/repair 1b's TOF's Sector 4; Cable/test/repair 1b's TOF's Sector 5; Cable/test/repair 1b's TOF's Sector 6
- 24264115: Steps: Conceptual design; 3D model; Drawings
- 24264910: Steps: Hand Calculations; FEA Analysis; Report
- 24264120: Steps: Hand Calculations; FEA Analysis; Report
- 24264230: Steps: Determine required wiring; Install wiring
- 24264145: Steps: Conceptual design; 3D model; Drawings

| ID | Activity | Type | Duration | Start | Finish | Predecessors | Total float | Free float | Calendar | Resources | Cost | Original Activity ID Rebaseline | RESP - Responsibility | STRT%COMP for CM EVM | FNSH%COMP for CM EVM | CAM RESPONSIBLE | CR 12-052 | CR 13-002 | BOE Labor | CR 13-015 | Post Rebaseline | CR 14-001 | PHAS - Project Phase | EVMS Reporting Codes | BOE Procurement | Advance Purchase Plan > 500K | CR 08-016 | 12 GEV MAJOR PROCUREMENT CATAGORY | CR 09-012 | CR 09-030 Repair | CR 11-026 | CR 11-035 | CR 12-027 | Activities with Steps | BOE Expenses | CR 09-030 | CR 12-024 | CR 11-022 | CR 13-010 |
| --- | --- | --- | --- | --- | --- | --- | --- | --- | --- | --- | --- | --- | --- | --- | --- | --- | --- | --- | --- | --- | --- | --- | --- | --- | --- | --- | --- | --- | --- | --- | --- | --- | --- | --- | --- | --- | --- | --- | --- |
| 24264540 | Distribution Can - purify system |  | 3d | 2014-10-01 | 2014-10-03 | 24264535 | 153d | 115d | 8/5 M-F w/JLAB Holidays ReBaseline | MECH TECH [80 h] | 3,785.6 | 24264525 | ELOUADRHIRI L | 1 | 1 | LATIFA E | 12-052 | 13-002 | PE | 13-015 | PR | 14-001 |  |  |  |  |  |  |  |  |  |  |  |  |  |  |  |  |  |
| 24264590 | Align Lower Cold ring beams and lock down |  | 7d | 2014-10-02 | 2014-10-10 | 24264585 | 25d | 0d | 8/5 M-F w/JLAB Holidays ReBaseline | MECH TECH [336 h] | 15,899.52 | 24264590 | ELOUADRHIRI L | 1 | 1 | LATIFA E | 12-052 | 13-002 | PE | 13-015 | PR | 14-001 |  |  |  |  |  |  |  |  |  |  |  |  |  |  |  |  |  |
| 24264125 | SVT - Procure SVT mounts and cart |  | 49d | 2014-10-06 | 2014-12-15 | 24264120, 24264110, 24264115 | 252d | 249d | 8/5 M-F w/JLAB Holidays ReBaseline | PROCUREMENT<$50K 60 | 33,137.4 | 24264125 | ELOUADRHIRI L | 1 | 1 | LATIFA E | 12-052 | 13-002 |  | 13-015 | PR | 14-001 | IN | D | PE |  |  |  |  |  |  |  |  |  |  |  |  |  |  |
| 24264915 | DC - procure cable trays and gas system mounts |  | 52d | 2014-10-09 | 2014-12-23 | 24264910, 24264905 FS-1d | 49d | 0d | 8/5 M-F w/JLAB Holidays ReBaseline | PROCUREMENT<$50K 60 | 34,536.66 | 24264915 | ELOUADRHIRI L | 1 | 1 | LATIFA E | 12-052 | 13-002 |  | 13-015 | PR | 14-001 | IN | D | PE | APP | 08-016 | 4211 | 09-012 | 09-030 | 11-026 | 11 -035 | 12-027 |  |  |  |  |  |  |
| 24264920 | DC - design maintenance platforms |  | 60d | 2014-10-10 | 2015-01-15 | 9-155M FS+7d | 166d | 0d | 8/5 M-F w/JLAB Holidays ReBaseline | PLABOR | 10,731.76 | 24264920 | ELOUADRHIRI L | 1 | 1 | LATIFA E | 12-052 | 13-002 |  | 13-015 | PR | 14-001 | IN | S |  | APP | 08-016 | 4211 | 09-012 | 09-030 | 11-026 | 11 -035 | 12-027 | ST | PE |  |  |  |  |
| 24264595 | Install Coil E and C Assemblies (mechanical) |  | 11d | 2014-10-13 | 2014-10-27 | 24264590, 242743015, 242743035 | 25d | 0d | 8/5 M-F w/JLAB Holidays ReBaseline | MECH TECH [528 h]; MECH ENG [88 h] | 31,555.92 | 24264595 | ELOUADRHIRI L | 1 | 1 | LATIFA E | 12-052 | 13-002 | PE | 13-015 | PR | 14-001 |  |  |  |  |  |  |  |  |  |  |  |  |  |  |  |  |  |
| 24264600 | Install Vertical Cold ring beams and braces |  | 10d | 2014-10-28 | 2014-11-10 | 24264595 | 25d | 5d | 8/5 M-F w/JLAB Holidays ReBaseline | MECH TECH [320 h] | 15,142.4 | 24264600 | ELOUADRHIRI L | 1 | 1 | LATIFA E | 12-052 | 13-002 | PE | 13-015 | PR | 14-001 |  |  |  |  |  |  |  |  |  |  |  |  |  |  |  |  |  |
| 24264605 | Install Coil F and B assemblies |  | 11d | 2014-11-18 | 2014-12-04 | 24264600, 242743055, 242743075 | 20d | 0d | 8/5 M-F w/JLAB Holidays ReBaseline | MECH TECH [528 h]; MECH ENG [88 h] | 31,555.92 | 24264605 | ELOUADRHIRI L | 1 | 1 | LATIFA E | 12-052 | 13-002 | PE | 13-015 | PR | 14-001 |  |  |  |  |  |  |  |  |  |  |  |  |  |  |  |  |  |
| 24264925 | DC - maintenance platforms Engineering Analysis |  | 15d | 2014-12-01 | 2014-12-19 | 24264920 FS-26d | 166d | 0d | 8/5 M-F w/JLAB Holidays ReBaseline | MECH ENG [120 h] | 8,960.4 | 24264925 | ELOUADRHIRI L | 1 | 1 | LATIFA E | 12-052 | 13-002 | PE | 13-015 | PR | 14-001 | IN | H |  | APP | 08-016 | 4211 | 09-012 | 09-030 | 11-026 | 11 -035 | 12-027 |  |  |  |  |  |  |
| 24264610 | Install Top four Cold Ring beams and temporary braces |  | 7d | 2014-12-05 | 2014-12-15 | 24264605 | 20d | 3d | 8/5 M-F w/JLAB Holidays ReBaseline | MECH TECH [224 h] | 10,599.68 | 24264610 | ELOUADRHIRI L | 1 | 1 | LATIFA E | 12-052 | 13-002 | PE | 13-015 | PR | 14-001 |  |  |  |  |  |  |  |  |  |  |  |  |  |  |  |  |  |
| 24264010M | SVT Ready For Installation | milestone | 0d | 2014-12-15 | 2014-12-15 | 242211918M | 229d | 226d | 8/5 M-F w/JLAB Holidays ReBaseline |  |  | 24264010M | ELOUADRHIRI L | 1 | 1 | LATIFA E | 12-052 | 13-002 |  | 13-015 | PR |  |  | M |  |  |  |  |  |  |  |  |  |  |  |  |  |  |  |
| 24264615 | Install Coil A |  | 6d | 2014-12-19 | 2015-01-07 | 24264090M, 242743095, 24264610 | 17d | 0d | 8/5 M-F w/JLAB Holidays ReBaseline | MECH TECH [288 h]; MECH ENG [24 h]; MECH DES [24 h] | 16,651.44 | 24264615 | ELOUADRHIRI L | 1 | 1 | LATIFA E | 12-052 | 13-002 | PE | 13-015 | PR | 14-001 |  |  |  |  |  |  |  |  |  |  |  |  |  |  |  |  |  |
| 24264160 | HTCC - procure transport cart |  | 41d | 2014-12-22 | 2015-02-27 | 24264145 | 194d | 174d | 8/5 M-F w/JLAB Holidays ReBaseline | PROCUREMENT<$50K 60 | 36,629.35 | 24264160 | ELOUADRHIRI L | 1 | 1 | LATIFA E | 12-052 | 13-002 |  | 13-015 | PR | 14-001 | IN | D | PE |  |  |  |  |  |  |  |  |  |  |  |  |  |  |
| 24264930 | DC - procure maintenance platforms |  | 41d | 2014-12-22 | 2015-02-27 | 24264925, 24264920 FS-20d | 166d | 149d | 8/5 M-F w/JLAB Holidays ReBaseline | PROCUREMENT<$50K 60 | 19,836.21 | 24264930 | ELOUADRHIRI L | 1 | 1 | LATIFA E | 12-052 | 13-002 |  | 13-015 | PR | 14-001 | IN | D | PE | APP | 08-016 | 4211 | 09-012 | 09-030 | 11-026 | 11 -035 | 12-027 |  |  |  |  |  |  |
| 24264095M | Torus Control System Ready for Installation | milestone | 0d | 2015-01-07 | 2015-01-07 | 24271740M FS+60d | 137d | 0d | 8/5 M-F w/JLAB Holidays ReBaseline |  |  | 24264095M | ELOUADRHIRI L | 1 | 1 | LATIFA E | 12-052 | 13-002 |  | 13-015 | PR |  |  | M |  |  |  |  |  |  |  |  |  |  |  |  |  |  |  |
| 24264555 | Install Torus Control System |  | 20d | 2015-01-07 | 2015-02-04 | 24264095M | 137d | 120d | 8/5 M-F w/JLAB Holidays ReBaseline | ELEC TECH [160 h]; ELEC ENG [160 h] | 19,539.2 | 24264555 | ELOUADRHIRI L | 1 | 1 | LATIFA E | 12-052 | 13-002 | PE | 13-015 | PR | 14-001 |  |  |  |  |  |  |  |  |  |  |  |  |  |  |  |  |  |
| 24264620 | Survey all CCM and Cold Hub relative locations adjust as necessary |  | 3d | 2015-01-08 | 2015-01-12 | 24264615 | 17d | 0d | 8/5 M-F w/JLAB Holidays ReBaseline | MECH ENG [24 h]; MECH TECH [108 h] | 6,902.64 | 24264620 | ELOUADRHIRI L | 1 | 1 | LATIFA E | 12-052 | 13-002 | PE | 13-015 | PR | 14-001 |  |  |  |  |  |  |  |  |  |  |  |  |  |  |  |  |  |
| 24264625 | Mount the Torus Service Module on Level 3 |  | 1d | 2015-01-13 | 2015-01-13 | 242751335, 24264620 | 17d | 0d | 8/5 M-F w/JLAB Holidays ReBaseline | MECH TECH [32 h]; MECH DES [4 h] | 1,719.44 | 24264625 | ELOUADRHIRI L | 1 | 1 | LATIFA E | 12-052 | 13-002 | PE | 13-015 | PR | 14-001 |  |  |  |  |  |  |  |  |  |  |  |  |  |  |  |  |  |
| 24264798M | Start Installation of Solenoid | milestone | 0d | 2015-01-13 | 2015-01-13 | 24272075k FS-10d, 24264794, 242781020, 2-35M FS+23d, 24264515, 24264797, 24264791 | 91d | 0d | 8/5 M-F w/JLAB Holidays ReBaseline |  |  | 24264798M | ELOUADRHIRI L | 1 | 1 | LATIFA E | 12-052 | 13-002 |  | 13-015 | PR |  | IN | M |  |  | 08-016 |  | 09-012 | 09-030 | 11-026 | 11 -035 |  |  |  | 09-030 | 12-024 |  |  |
| 24264800 | Receive and inspect solenoid magnet from Vendor |  | 3d | 2015-01-13 | 2015-01-15 | 24264798M | 91d | 0d | 8/5 M-F w/JLAB Holidays ReBaseline | MECH TECH [160 h]; MECH ENG [80 h]; ELEC TECH [80 h] | 17,304 | 24264800 | ELOUADRHIRI L | 1 | 1 | LATIFA E | 12-052 | 13-002 | PE | 13-015 | PR | 14-001 | IN | S |  |  |  |  |  | 09-030 | 11-026 | 11 -035 |  |  |  | 09-030 | 12-024 | 11-022 |  |
| 24264805 | Install Solenoid cart |  | 1d | 2015-01-13 | 2015-01-13 | 24264800 FS-10d, 24264794a, 24264797, 24264798M | 93d | 2d | 8/5 M-F w/JLAB Holidays ReBaseline | MECH TECH [32 h] | 1,514.24 | 24264805 | ELOUADRHIRI L | 1 | 1 | LATIFA E | 12-052 | 13-002 | PE | 13-015 | PR | 14-001 | IN | H |  |  |  |  |  | 09-030 | 11-026 | 11 -035 |  |  |  | 09-030 | 12-024 | 11-022 |  |
| 24264630 | Splice all Coil Leads and Leads to Service Module |  | 4d | 2015-01-14 | 2015-01-20 | 24264625 | 17d | 0d | 8/5 M-F w/JLAB Holidays ReBaseline | MECH ENG [32 h]; MECH TECH [96 h] | 6,932.16 | 24264630 | ELOUADRHIRI L | 1 | 1 | LATIFA E | 12-052 | 13-002 | PE | 13-015 | PR | 14-001 |  |  |  |  |  |  |  |  |  |  |  |  |  |  |  |  |  |
| 24264880 | Vend Fab Drift Chambers Installation tooling |  | 100d | 2015-01-14 | 2015-06-05 | 9-155M FS+65d | 98d | 81d | 8/5 M-F w/JLAB Holidays ReBaseline | PROCUREMENT<$50K 60 | 21,060.11 | 24264880 | ELOUADRHIRI L | 1 | 1 | LATIFA E | 12-052 | 13-002 |  | 13-015 | PR | 14-001 | IN | D | PE |  |  |  |  | 09-030 | 11-026 | 11 -035 | 12-027 |  |  | 09-030 |  |  |  |
| 24264810 | Assemble Solenoid and Piping |  | 30d | 2015-01-16 | 2015-02-27 | 24264805, 24264800 | 91d | 88d | 8/5 M-F w/JLAB Holidays ReBaseline | PLABOR; MECH TECH [240 h] | 20,147.08 | 24264810 | ELOUADRHIRI L | 1 | 1 | LATIFA E | 12-052 | 13-002 | PE | 13-015 | PR | 14-001 |  | S |  |  |  |  |  |  |  | 11 -035 |  |  | PE |  | 12-024 |  |  |
| 24264635 | Weld/Braze all cooling lines (He) |  | 2d | 2015-01-21 | 2015-01-22 | 24264630 | 17d | 0d | 8/5 M-F w/JLAB Holidays ReBaseline | MECH TECH [48 h] | 2,271.36 | 24264635 | ELOUADRHIRI L | 1 | 1 | LATIFA E | 12-052 | 13-002 | PE | 13-015 | PR | 14-001 |  |  |  |  |  |  |  |  |  |  |  |  |  |  |  |  |  |
| 24264640 | Pressure and Leak test all 4K cooling lines |  | 2d | 2015-01-23 | 2015-01-26 | 24264635 | 17d | 0d | 8/5 M-F w/JLAB Holidays ReBaseline | MECH TECH [32 h]; MECH ENG [16 h] | 2,708.96 | 24264640 | ELOUADRHIRI L | 1 | 1 | LATIFA E | 12-052 | 13-002 | PE | 13-015 | PR | 14-001 |  |  |  |  |  |  |  |  |  |  |  |  |  |  |  |  |  |
| 24264645 | Secure and Heat Station the Splices and coil leads |  | 3d | 2015-01-27 | 2015-01-29 | 24264640 | 17d | 0d | 8/5 M-F w/JLAB Holidays ReBaseline | MECH TECH [72 h] | 3,407.04 | 24264645 | ELOUADRHIRI L | 1 | 1 | LATIFA E | 12-052 | 13-002 | PE | 13-015 | PR | 14-001 |  |  |  |  |  |  |  |  |  |  |  |  |  |  |  |  |  |
| 24264650 | Connect all instrumentation including voltage taps |  | 6d | 2015-01-30 | 2015-02-06 | 24264645 | 17d | 0d | 8/5 M-F w/JLAB Holidays ReBaseline | MECH TECH [96 h]; ELEC TECH [96 h] | 9,053.76 | 24264650 | ELOUADRHIRI L | 1 | 1 | LATIFA E | 12-052 | 13-002 | PE | 13-015 | PR | 14-001 |  |  |  |  |  |  |  |  |  |  |  |  |  |  |  |  |  |
| 24264655 | Insulate all 4K Surfaces |  | 10d | 2015-02-09 | 2015-02-20 | 242751300, 24264650, 242751260, 242751310 | 17d | 0d | 8/5 M-F w/JLAB Holidays ReBaseline | MECH DES [40 h]; MECH ENG [40 h]; MECH TECH [320 h] | 20,181.2 | 24264655 | ELOUADRHIRI L | 1 | 1 | LATIFA E | 12-052 | 13-002 | PE | 13-015 | PR | 14-001 |  |  |  |  |  |  |  |  |  |  |  |  |  |  |  |  |  |
| 24264065M | LTCC - Last 3 units Ready for Installation | milestone | 0d | 2015-02-11 | 2015-02-11 | 242242500M | 185d | 0d | 8/5 M-F w/JLAB Holidays ReBaseline |  |  | 24264065M | ELOUADRHIRI L | 1 | 1 | LATIFA E | 12-052 | 13-002 |  | 13-015 | PR |  |  | M |  |  |  |  |  |  |  |  |  |  |  |  |  |  |  |
| 24264460 | Transport and Install LTCC |  | 10d | 2015-02-20 | 2015-03-05 | 24264055M FS-4d, 24264065M FS+7d, 24264430 FS-4d, 24264435 FS-4d, 24264285 | 185d | 0d | 8/5 M-F w/JLAB Holidays ReBaseline | MECH TECH [320 h] | 15,142.4 | 24264460 | ELOUADRHIRI L | 1 | 1 | LATIFA E | 12-052 | 13-002 | PE | 13-015 | PR | 14-001 |  | S |  |  |  |  |  |  |  |  |  | ST |  |  |  |  |  |
| 24264660 | Complete Central hub heat shield |  | 4d | 2015-02-23 | 2015-02-26 | 24264655 | 17d | 0d | 8/5 M-F w/JLAB Holidays ReBaseline | MECH TECH [96 h] | 4,542.72 | 24264660 | ELOUADRHIRI L | 1 | 1 | LATIFA E | 12-052 | 13-002 | PE | 13-015 | PR | 14-001 |  |  |  |  |  |  |  |  |  |  |  |  |  |  |  |  |  |
| 24264762 | TORUS CRYO WARM PIPING-Design Gas Panel and Piping |  | 15d | 2015-02-24 | 2015-03-16 | 24264760 FS-70d | 29d | 0d | 8/5 M-F w/JLAB Holidays ReBaseline | MECH ENG [120 h] | 8,960.4 | 24264762 | ELOUADRHIRI L | 1 | 1 | LATIFA E | 12-052 | 13-002 | PE | 13-015 | PR | 14-001 |  |  |  |  |  |  |  |  |  |  |  |  | PE |  |  |  |  |
| 24264665 | Install Cold to warm supports on vertical Cold ring beams |  | 1d | 2015-02-27 | 2015-02-27 | 24264660 | 17d | 0d | 8/5 M-F w/JLAB Holidays ReBaseline | MECH TECH [32 h]; MECH ENG [4 h]; MECH DES [4 h] | 2,018.12 | 24264665 | ELOUADRHIRI L | 1 | 1 | LATIFA E | 12-052 | 13-002 | PE | 13-015 | PR | 14-001 |  |  |  |  |  |  |  |  |  |  |  |  |  |  |  |  |  |
| 24264670 | Install Heat shield on Cold Ring vertical Beams |  | 4d | 2015-03-02 | 2015-03-05 | 24264665 | 17d | 0d | 8/5 M-F w/JLAB Holidays ReBaseline | MECH TECH [128 h] | 6,056.96 | 24264670 | ELOUADRHIRI L | 1 | 1 | LATIFA E | 12-052 | 13-002 | PE | 13-015 | PR | 14-001 |  |  |  |  |  |  |  |  |  |  |  |  |  |  |  |  |  |
| 24264465 | Survey (as found location) LTCC positions |  | 3d | 2015-03-06 | 2015-03-10 | 24264460 | 185d | 0d | 8/5 M-F w/JLAB Holidays ReBaseline | MECH TECH [72 h] | 3,407.04 | 24264465 | ELOUADRHIRI L | 1 | 1 | LATIFA E | 12-052 | 13-002 | PE | 13-015 | PR | 14-001 |  | H |  |  |  |  |  |  |  |  |  |  |  |  |  |  |  |
| 24264675 | Insulate 80K surfaces on Cold Ring vertical beams |  | 4d | 2015-03-06 | 2015-03-11 | 24264670 | 17d | 0d | 8/5 M-F w/JLAB Holidays ReBaseline | MECH TECH [128 h]; MECH ENG [16 h]; MECH DES [16 h] | 8,072.48 | 24264675 | ELOUADRHIRI L | 1 | 1 | LATIFA E | 12-052 | 13-002 | PE | 13-015 | PR | 14-001 |  |  |  |  |  |  |  |  |  |  |  |  |  |  |  |  |  |
| 24264470 | Cable/test/repair LTCC's |  | 6d | 2015-03-10 | 2015-03-17 | 24264465 FS-1d | 195d | 192d | 8/5 M-F w/JLAB Holidays ReBaseline | MECH TECH [96 h]; SCIENTIST [48 h] | 8,151.36 | 24264470 | ELOUADRHIRI L | 1 | 1 | LATIFA E | 12-052 | 13-002 | PE | 13-015 | PR | 14-001 |  | H |  |  |  |  |  |  |  |  |  |  |  |  |  |  |  |
| 24264490 | Transport and Install TOF Panel 2 and align relative to panel 1a |  | 6d | 2015-03-11 | 2015-03-18 | 24264065M, 24264045M, 24264460, 24264465 | 185d | 0d | 8/5 M-F w/JLAB Holidays ReBaseline | MECH TECH [192 h] | 9,085.44 | 24264490 | ELOUADRHIRI L | 1 | 1 | LATIFA E | 12-052 | 13-002 | PE | 13-015 | PR | 14-001 |  | H |  |  |  |  |  |  |  |  |  |  |  |  |  |  |  |
| 24264680 | Install Outer Legs N & S on Adjusters (includes 1/2 of CS VJ) |  | 2d | 2015-03-12 | 2015-03-13 | 24264675 | 17d | 0d | 8/5 M-F w/JLAB Holidays ReBaseline | MECH ENG [16 h]; MECH TECH [112 h] | 6,494.56 | 24264680 | ELOUADRHIRI L | 1 | 1 | LATIFA E | 12-052 | 13-002 | PE | 13-015 | PR | 14-001 |  |  |  |  |  |  |  |  |  |  |  |  |  |  |  |  |  |
| 24264685 | Attach cold to warm support to VJ (2 places) |  | 1d | 2015-03-16 | 2015-03-16 | 24264680 | 17d | 0d | 8/5 M-F w/JLAB Holidays ReBaseline | MECH TECH [32 h]; MECH ENG [8 h] | 2,111.6 | 24264685 | ELOUADRHIRI L | 1 | 1 | LATIFA E | 12-052 | 13-002 | PE | 13-015 | PR | 14-001 |  |  |  |  |  |  |  |  |  |  |  |  |  |  |  |  |  |
| 24264690 | Complete Vertical Cold Ring VJ |  | 4d | 2015-03-17 | 2015-03-20 | 24264685 | 17d | 0d | 8/5 M-F w/JLAB Holidays ReBaseline | MECH ENG [32 h]; MECH TECH [224 h] | 12,989.12 | 24264690 | ELOUADRHIRI L | 1 | 1 | LATIFA E | 12-052 | 13-002 | PE | 13-015 | PR | 14-001 |  |  |  |  |  |  |  |  |  |  |  |  |  |  |  |  |  |
| 24264762A | TORUS CRYO WARM PIPING-Cut Back Piping |  | 1d | 2015-03-17 | 2015-03-17 | 24264762 | 29d | 0d | 8/5 M-F w/JLAB Holidays ReBaseline | MECH TECH [16 h] | 757.12 | 24264762 | ELOUADRHIRI L | 1 | 1 | LATIFA E | 12-052 | 13-002 | PE | 13-015 | PR | 14-001 |  |  |  |  |  |  |  |  |  |  |  |  | PE |  |  |  |  |
| 24264762B | TORUS CRYO WARM PIPING-Procure valves and fitting |  | 20d | 2015-03-18 | 2015-04-14 | 24264762A | 29d | 0d | 8/5 M-F w/JLAB Holidays ReBaseline | MECH ENG [160 h]; SUPPLIES & MATERIALS | 22,266.2 | 24264762 | ELOUADRHIRI L | 1 | 1 | LATIFA E | 12-052 | 13-002 | PE | 13-015 | PR | 14-001 |  |  |  |  |  |  |  |  |  |  |  |  | PE |  |  |  |  |
| 24264495 | Final Survey TOF panel 2's Positions |  | 3d | 2015-03-19 | 2015-03-23 | 24264490 | 185d | 0d | 8/5 M-F w/JLAB Holidays ReBaseline | MECH TECH [72 h] | 3,407.04 | 24264495 | ELOUADRHIRI L | 1 | 1 | LATIFA E | 12-052 | 13-002 | PE | 13-015 | PR | 14-001 |  | H |  |  |  |  |  |  |  |  |  |  |  |  |  |  |  |
| 24264695 | Transfer load from Temporary legs to Outer Legs and Remove Temp legs |  | 2d | 2015-03-23 | 2015-03-24 | 24264690 | 17d | 0d | 8/5 M-F w/JLAB Holidays ReBaseline | MECH ENG [8 h]; MECH DES [8 h]; MECH TECH [64 h] | 4,036.24 | 24264695 | ELOUADRHIRI L | 1 | 1 | LATIFA E | 12-052 | 13-002 | PE | 13-015 | PR | 14-001 |  |  |  |  |  |  |  |  |  |  |  |  |  |  |  |  |  |
| 24264500 | Cable/test/repair Panel 2 TOFs |  | 6d | 2015-03-24 | 2015-03-31 | 24264495, 24264490 FS-5d | 185d | 182d | 8/5 M-F w/JLAB Holidays ReBaseline | MECH TECH [96 h]; SCIENTIST [48 h] | 8,151.36 | 24264500 | ELOUADRHIRI L | 1 | 1 | LATIFA E | 12-052 | 13-002 | PE | 13-015 | PR | 14-001 |  | H |  |  |  |  |  |  |  |  |  |  |  |  |  |  |  |
| 24264700 | Install Heat Shield on other 8 Hex Ring beams |  | 8d | 2015-03-25 | 2015-04-03 | 24264695 | 17d | 0d | 8/5 M-F w/JLAB Holidays ReBaseline | MECH ENG [64 h]; MECH TECH [448 h] | 25,978.24 | 24264700 | ELOUADRHIRI L | 1 | 1 | LATIFA E | 12-052 | 13-002 | PE | 13-015 | PR | 14-001 |  |  |  |  |  |  |  |  |  |  |  |  |  |  |  |  |  |
| 24264757 | TORUS CRYOTOWER-Transport and position cryotower |  | 2d | 2015-03-31 | 2015-04-01 | 24264690, 24264525 FS-1d, 24264540, 242762045 | 38d | 0d | 8/5 M-F w/JLAB Holidays ReBaseline | MECH TECH [48 h] | 2,271.36 | 24264757 | ELOUADRHIRI L | 1 | 1 | LATIFA E | 12-052 | 13-002 | PE | 13-015 | PR | 14-001 |  |  |  |  |  |  |  |  |  |  |  |  |  |  |  |  |  |
| 24264020M | R3 Drift Chambers Ready for Installation | milestone | 0d | 2015-04-02 | 2015-04-02 | 242213355M | 165d | 148d | 8/5 M-F w/JLAB Holidays ReBaseline |  |  | 24264020M | ELOUADRHIRI L | 1 | 1 | LATIFA E | 12-052 | 13-002 |  | 13-015 | PR |  |  | M |  |  |  |  |  |  |  |  |  |  |  |  |  |  |  |
| 24264757A | TORUS CRYOTOWER-Connect cold piping with fittings and welding |  | 10d | 2015-04-02 | 2015-04-15 | 24264757 | 38d | 0d | 8/5 M-F w/JLAB Holidays ReBaseline | MECH TECH [240 h] | 11,356.8 | 24264757 | ELOUADRHIRI L | 1 | 1 | LATIFA E | 12-052 | 13-002 | PE | 13-015 | PR | 14-001 |  |  |  |  |  |  |  |  |  |  |  |  |  |  |  |  |  |
| 24264757B | TORUS CRYOTOWER-Connect Instrumentation, valves and current leads |  | 8d | 2015-04-02 | 2015-04-13 | 24264757A FS-10d | 38d | 0d | 8/5 M-F w/JLAB Holidays ReBaseline | MECH TECH [192 h] | 9,085.44 | 24264757 | ELOUADRHIRI L | 1 | 1 | LATIFA E | 12-052 | 13-002 | PE | 13-015 | PR | 14-001 |  |  |  |  |  |  |  |  |  |  |  |  |  |  |  |  |  |
| 24264705 | Connect all Heat Shield cooling tubes |  | 3d | 2015-04-06 | 2015-04-08 | 24264700 | 17d | 0d | 8/5 M-F w/JLAB Holidays ReBaseline | MECH TECH [96 h] | 4,542.72 | 24264705 | ELOUADRHIRI L | 1 | 1 | LATIFA E | 12-052 | 13-002 | PE | 13-015 | PR | 14-001 |  |  |  |  |  |  |  |  |  |  |  |  |  |  |  |  |  |
| 24264868 | Design and install HTCC gas system |  | 90d | 2015-04-08 | 2015-08-14 | 9-155M FS+124d | 77d | 57d | 8/5 M-F w/JLAB Holidays ReBaseline | MECH TECH [240 h]; MECH DES [120 h] | 17,512.8 | 24264868 | ELOUADRHIRI L | 1 | 1 | LATIFA E | 12-052 | 13-002 | PE | 13-015 | PR | 14-001 |  | S |  |  |  |  |  |  |  | 11 -035 |  | ST |  |  | 12-024 |  | 13-010 |
| 24264710 | Pressure and Leak test all 80K cooling lines |  | 2d | 2015-04-09 | 2015-04-10 | 24264705 | 17d | 0d | 8/5 M-F w/JLAB Holidays ReBaseline | MECH TECH [32 h]; MECH ENG [16 h] | 2,708.96 | 24264710 | ELOUADRHIRI L | 1 | 1 | LATIFA E | 12-052 | 13-002 | PE | 13-015 | PR | 14-001 |  |  |  |  |  |  |  |  |  |  |  |  |  |  |  |  |  |
| 24264340M | Start Beamline Modifications | milestone | 0d | 2015-04-13 | 2015-04-13 | 24254120 FS-120d | 152d | 0d | 8/5 M-F w/JLAB Holidays ReBaseline |  |  | 24264340M | ELOUADRHIRI L | 1 | 1 | LATIFA E | 12-052 | 13-002 |  | 13-015 | PR |  | IN | M |  |  |  |  |  |  |  |  |  |  |  |  |  |  |  |
| 24264350 | Move Moeller Quads and Table |  | 15d | 2015-04-13 | 2015-05-01 | 24264340M | 152d | 0d | 8/5 M-F w/JLAB Holidays ReBaseline | MECH TECH [240 h] | 11,356.8 | 24264350 | ELOUADRHIRI L | 1 | 1 | LATIFA E | 12-052 | 13-002 | PE | 13-015 | PR | 14-001 | IN | S |  |  |  |  |  |  |  |  |  | ST |  |  |  |  |  |
| 24264715 | Insulate All 80K Surfaces |  | 6d | 2015-04-13 | 2015-04-20 | 24264710 | 17d | 0d | 8/5 M-F w/JLAB Holidays ReBaseline | MECH ENG [24 h]; MECH DES [24 h]; MECH TECH [192 h] | 12,108.72 | 24264715 | ELOUADRHIRI L | 1 | 1 | LATIFA E | 12-052 | 13-002 | PE | 13-015 | PR | 14-001 |  |  |  |  |  |  |  |  |  |  |  |  |  |  |  |  |  |
| 24264757C | TORUS CRYOTOWER-Leak Test new System |  | 4d | 2015-04-14 | 2015-04-17 | 24264757B | 38d | 0d | 8/5 M-F w/JLAB Holidays ReBaseline | MECH TECH [96 h] | 4,542.72 | 24264757 | ELOUADRHIRI L | 1 | 1 | LATIFA E | 12-052 | 13-002 | PE | 13-015 | PR | 14-001 |  |  |  |  |  |  |  |  |  |  |  |  |  |  |  |  |  |
| 24264762C | TORUS CRYO WARM PIPING-Install New Piping |  | 10d | 2015-04-15 | 2015-04-28 | 24264762B | 29d | 0d | 8/5 M-F w/JLAB Holidays ReBaseline | MECH TECH [160 h] | 7,571.2 | 24264762 | ELOUADRHIRI L | 1 | 1 | LATIFA E | 12-052 | 13-002 | PE | 13-015 | PR | 14-001 |  |  |  |  |  |  |  |  |  |  |  |  | PE |  |  |  |  |
| 24264080M | HTCC Ready for Installation | milestone | 0d | 2015-04-20 | 2015-04-20 | 242241650M | 157d | 137d | 8/5 M-F w/JLAB Holidays ReBaseline |  |  | 24264080M | ELOUADRHIRI L | 1 | 1 | LATIFA E | 12-052 | 13-002 |  | 13-015 | PR |  |  | M |  |  |  |  |  |  |  |  |  |  |  |  |  |  |  |
| 24264757D | TORUS CRYOTOWER-Pressure Test Piping |  | 2d | 2015-04-20 | 2015-04-21 | 24264757C | 38d | 0d | 8/5 M-F w/JLAB Holidays ReBaseline | MECH TECH [48 h] | 2,271.36 | 24264757 | ELOUADRHIRI L | 1 | 1 | LATIFA E | 12-052 | 13-002 | PE | 13-015 | PR | 14-001 |  |  |  |  |  |  |  |  |  |  |  |  |  |  |  |  |  |
| 24264720 | Install VJ on other 8 Hex Ring Beams |  | 8d | 2015-04-21 | 2015-04-30 | 24264715 | 17d | 0d | 8/5 M-F w/JLAB Holidays ReBaseline | MECH TECH [448 h]; MECH ENG [64 h] | 25,978.24 | 24264720 | ELOUADRHIRI L | 1 | 1 | LATIFA E | 12-052 | 13-002 | PE | 13-015 | PR | 14-001 |  |  |  |  |  |  |  |  |  |  |  |  |  |  |  |  |  |
| 24264757F | TORUS CRYOTOWER-Final Leak Test system |  | 3d | 2015-04-22 | 2015-04-24 | 24264757D | 38d | 0d | 8/5 M-F w/JLAB Holidays ReBaseline | MECH TECH [72 h] | 3,407.04 | 24264757 | ELOUADRHIRI L | 1 | 1 | LATIFA E | 12-052 | 13-002 | PE | 13-015 | PR | 14-001 |  |  |  |  |  |  |  |  |  |  |  |  |  |  |  |  |  |
| 24264757G | Purify System |  | 3d | 2015-04-27 | 2015-04-29 | 24264757F | 38d | 21d | 8/5 M-F w/JLAB Holidays ReBaseline | MECH TECH [60 h] | 2,839.2 | 24264757 | ELOUADRHIRI L | 1 | 1 | LATIFA E | 12-052 | 13-002 | PE | 13-015 | PR | 14-001 |  |  |  |  |  |  |  |  |  |  |  |  |  |  |  |  |  |
| 24264762D | TORUS CRYO WARM PIPING-Leak Test new Piping |  | 4d | 2015-04-29 | 2015-05-04 | 24264762C | 29d | 0d | 8/5 M-F w/JLAB Holidays ReBaseline | MECH TECH [64 h] | 3,028.48 | 24264762 | ELOUADRHIRI L | 1 | 1 | LATIFA E | 12-052 | 13-002 | PE | 13-015 | PR | 14-001 |  |  |  |  |  |  |  |  |  |  |  |  | PE |  |  |  |  |
| 24264723 | Install insulation and shield and VJ at central Hub |  | 4d | 2015-05-01 | 2015-05-06 | 24264720 | 17d | 0d | 8/5 M-F w/JLAB Holidays ReBaseline | MECH DES [16 h]; MECH ENG [16 h]; MECH TECH [64 h] | 5,044 | 24264723 | ELOUADRHIRI L | 1 | 1 | LATIFA E | 12-052 | 13-002 | PE | 13-015 | PR | 14-001 |  |  |  |  |  |  |  |  |  |  |  |  |  |  |  |  | 13-010 |
| 24264355 | Move GONI |  | 7d | 2015-05-04 | 2015-05-12 | 24264350 | 152d | 0d | 8/5 M-F w/JLAB Holidays ReBaseline | MECH TECH [80 h] | 3,785.6 | 24264355 | ELOUADRHIRI L | 1 | 1 | LATIFA E | 12-052 | 13-002 | PE | 13-015 | PR | 14-001 |  | H |  |  |  |  |  |  |  |  |  |  |  |  |  |  |  |
| 24264762F | TORUS CRYO WARM PIPING-Pressure Test Piping |  | 1d | 2015-05-05 | 2015-05-05 | 24264762D | 29d | 0d | 8/5 M-F w/JLAB Holidays ReBaseline | MECH TECH [16 h] | 757.12 | 24264762 | ELOUADRHIRI L | 1 | 1 | LATIFA E | 12-052 | 13-002 | PE | 13-015 | PR | 14-001 |  |  |  |  |  |  |  |  |  |  |  |  | PE |  |  |  |  |
| 24264762G | TORUS CRYO WARM PIPING-Final Leak Test system |  | 4d | 2015-05-06 | 2015-05-11 | 24264762F | 29d | 0d | 8/5 M-F w/JLAB Holidays ReBaseline | MECH TECH [64 h] | 3,028.48 | 24264762 | ELOUADRHIRI L | 1 | 1 | LATIFA E | 12-052 | 13-002 | PE | 13-015 | PR | 14-001 |  |  |  |  |  |  |  |  |  |  |  |  | PE |  |  |  |  |

Notes:
- 24264920: Steps: Conceptual design; 3D model; Drawings
- 24264460: Steps: Transport and Install LTCC sector 1; Transport and Install LTCC sector 2; Transport and Install LTCC sector 3; Transport and Install LTCC sector 4; Transport and Install LTCC sector 5; Transport and Install LTCC sector 6
- 24264868: Steps: Design HTCC gas system; Install gas system
- 24264350: Steps: Move 1 moeller quad magnet; Move table

| ID | Activity | Type | Duration | Start | Finish | Predecessors | Total float | Free float | Calendar | Resources | Cost | Original Activity ID Rebaseline | RESP - Responsibility | STRT%COMP for CM EVM | FNSH%COMP for CM EVM | CAM RESPONSIBLE | CR 12-052 | CR 13-002 | BOE Labor | CR 13-015 | Post Rebaseline | CR 14-001 | BOE Expenses | EVMS Reporting Codes | CR 13-010 | CR 11-035 | CR 12-024 | PHAS - Project Phase | CR 09-030 | CR 09-030 Repair | CR 11-026 | Activities with Steps | BOE Procurement | CR 08-016 | CR 09-012 | CR 10-005 | CR 11-022 | CR 12-007 |
| --- | --- | --- | --- | --- | --- | --- | --- | --- | --- | --- | --- | --- | --- | --- | --- | --- | --- | --- | --- | --- | --- | --- | --- | --- | --- | --- | --- | --- | --- | --- | --- | --- | --- | --- | --- | --- | --- | --- |
| 24264725 | Install VJ between Coils at Hub |  | 6d | 2015-05-07 | 2015-05-14 | 24264723 | 17d | 0d | 8/5 M-F w/JLAB Holidays ReBaseline | MECH ENG [48 h]; MECH TECH [336 h] | 19,483.68 | 24264725 | ELOUADRHIRI L | 1 | 1 | LATIFA E | 12-052 | 13-002 | PE | 13-015 | PR | 14-001 |  |  |  |  |  |  |  |  |  |  |  |  |  |  |  |  |
| 24264762H | TORUS CRYO WARM PIPING-Purify System |  | 3d | 2015-05-12 | 2015-05-14 | 24264762G | 29d | 12d | 8/5 M-F w/JLAB Holidays ReBaseline | MECH TECH [40 h] | 1,892.8 | 24264762 | ELOUADRHIRI L | 1 | 1 | LATIFA E | 12-052 | 13-002 | PE | 13-015 | PR | 14-001 | PE |  |  |  |  |  |  |  |  |  |  |  |  |  |  |  |
| 24264360 | Align Goni and Moeller Quads |  | 3d | 2015-05-13 | 2015-05-15 | 24264355 | 152d | 149d | 8/5 M-F w/JLAB Holidays ReBaseline | MECH TECH [24 h] | 1,135.68 | 24264360 | ELOUADRHIRI L | 1 | 1 | LATIFA E | 12-052 | 13-002 | PE | 13-015 | PR | 14-001 |  | H |  |  |  |  |  |  |  |  |  |  |  |  |  |  |
| 24264730 | Transfer All Cold Mass Loads to VJ |  | 2d | 2015-05-15 | 2015-05-18 | 24264725 | 17d | 0d | 8/5 M-F w/JLAB Holidays ReBaseline | MECH TECH [64 h]; MECH ENG [16 h] | 4,223.2 | 24264730 | ELOUADRHIRI L | 1 | 1 | LATIFA E | 12-052 | 13-002 | PE | 13-015 | PR | 14-001 |  |  |  |  |  |  |  |  |  |  |  |  |  |  |  |  |
| 24264735 | Align VJ to Beam Line |  | 2d | 2015-05-19 | 2015-05-20 | 24264730 | 17d | 0d | 8/5 M-F w/JLAB Holidays ReBaseline | MECH ENG [16 h]; MECH TECH [72 h] | 4,601.76 | 24264735 | ELOUADRHIRI L | 1 | 1 | LATIFA E | 12-052 | 13-002 | PE | 13-015 | PR | 14-001 |  |  |  |  |  |  |  |  |  |  |  |  |  |  |  |  |
| 24264740 | Align Cold Mass to VJ and Beam Line |  | 2d | 2015-05-21 | 2015-05-22 | 24264735 | 17d | 0d | 8/5 M-F w/JLAB Holidays ReBaseline | MECH TECH [72 h]; MECH ENG [16 h] | 4,601.76 | 24264740 | ELOUADRHIRI L | 1 | 1 | LATIFA E | 12-052 | 13-002 | PE | 13-015 | PR | 14-001 |  |  |  |  |  |  |  |  |  |  |  |  |  |  |  |  |
| 24264755 | Close up all cold mass view ports and temporary CCM support ports |  | 4d | 2015-05-26 | 2015-05-29 | 24264740 | 17d | 0d | 8/5 M-F w/JLAB Holidays ReBaseline | MECH TECH [96 h] | 4,542.72 | 24264755 | ELOUADRHIRI L | 1 | 1 | LATIFA E | 12-052 | 13-002 | PE | 13-015 | PR | 14-001 |  |  | 13-010 |  |  |  |  |  |  |  |  |  |  |  |  |  |
| 24264760 | TORUS CRYO WARM PIPING-Install Vacuum pumping system |  | 2d | 2015-06-02 | 2015-06-03 | 24264757G, 24264755 | 17d | 0d | 8/5 M-F w/JLAB Holidays ReBaseline | MECH TECH [72 h]; MECH ENG [16 h]; ELEC TECH [16 h] | 5,353.6 | 24264760 | ELOUADRHIRI L | 1 | 1 | LATIFA E | 12-052 | 13-002 | PE | 13-015 | PR | 14-001 |  |  | 13-010 |  |  |  |  |  |  |  |  |  |  |  |  |  |
| 24264765 | Pump VJ, leak and pressure test |  | 10d | 2015-06-04 | 2015-06-17 | 24264760, 24264762H | 17d | 0d | 8/5 M-F w/JLAB Holidays ReBaseline | MECH TECH [80 h] | 3,785.6 | 24264765 | ELOUADRHIRI L | 1 | 1 | LATIFA E | 12-052 | 13-002 | PE | 13-015 | PR | 14-001 |  |  | 13-010 |  |  |  |  |  |  |  |  |  |  |  |  |  |
| 24264770 | Install mounting adapters for drift chambers |  | 10d | 2015-06-18 | 2015-07-01 | 24264765, 24264755, 24264900 | 17d | 0d | 8/5 M-F w/JLAB Holidays ReBaseline | MECH TECH [327.6 h]; MECH ENG [120 h] | 24,462.43 | 24264770 | ELOUADRHIRI L | 1 | 1 | LATIFA E | 12-052 | 13-002 | PE | 13-015 | PR | 14-001 |  |  | 13-010 |  |  |  |  |  |  |  |  |  |  |  |  |  |
| 24264775 | Connect instrumentation and Leads |  | 5d | 2015-07-02 | 2015-07-09 | 24264760, 242771035, 24264770 | 17d | 0d | 8/5 M-F w/JLAB Holidays ReBaseline | ELEC TECH [216 h]; MECH ENG [40 h]; MECH TECH [100 h]; ELEC ENG [40 h] | 20,873.84 | 24264775 | ELOUADRHIRI L | 1 | 1 | LATIFA E | 12-052 | 13-002 | PE | 13-015 | PR | 14-001 |  |  | 13-010 |  |  |  |  |  |  |  |  |  |  |  |  |  |
| 24264815 | Solenoid instrumentation and current leads |  | 10d | 2015-07-06 | 2015-07-17 | 24264810 FS-1d, 242710.1030, 242791060 FS-1d | 3d | 0d | 8/5 M-F w/JLAB Holidays ReBaseline | ELEC TECH [160 h] | 7,518.4 | 24264815 | ELOUADRHIRI L | 1 | 1 | LATIFA E | 12-052 | 13-002 | PE | 13-015 | PR | 14-001 |  | H |  | 11 -035 | 12-024 |  |  |  |  |  |  |  |  |  |  |  |
| 24264780 | Connect Torus cryo lines |  | 2d | 2015-07-10 | 2015-07-13 | 24264770, 24264775 | 17d | 0d | 8/5 M-F w/JLAB Holidays ReBaseline | MECH ENG [40 h]; MECH TECH [132 h] | 9,233.04 | 24264780 | ELOUADRHIRI L | 1 | 1 | LATIFA E | 12-052 | 13-002 | PE | 13-015 | PR | 14-001 |  |  | 13-010 |  |  |  |  |  |  |  |  |  |  |  |  |  |
| 24264886 | Install DC HV/LV Racks and cable trays |  | 22d | 2015-07-16 | 2015-08-14 | 24264884 FS-70d | 49d | 32d | 8/5 M-F w/JLAB Holidays ReBaseline | MECH TECH [192 h] | 9,085.44 | 24264886 | ELOUADRHIRI L | 1 | 1 | LATIFA E | 12-052 | 13-002 | PE | 13-015 | PR | 14-001 |  | H |  | 11 -035 | 12-024 | IN | 09-030 | 09-030 | 11-026 |  |  |  |  |  |  |  |
| 24264820 | Align Solenoid |  | 2d | 2015-07-17 | 2015-07-20 | 24264815 FS-1d | 3d | 0d | 8/5 M-F w/JLAB Holidays ReBaseline | MECH TECH [16 h] | 757.12 | 24264820 | ELOUADRHIRI L | 1 | 1 | LATIFA E | 12-052 | 13-002 | PE | 13-015 | PR | 14-001 |  | H |  | 11 -035 | 12-024 |  |  |  |  |  |  |  |  |  |  |  |
| 24264825 | Connect Solenoid Cryo lines |  | 20d | 2015-07-21 | 2015-08-17 | 24264820 | 3d | 0d | 8/5 M-F w/JLAB Holidays ReBaseline |  |  | 24264825 | ELOUADRHIRI L | 1 | 1 | LATIFA E | 12-052 | 13-002 |  | 13-015 | PR |  |  | Z |  |  |  |  |  |  |  |  |  |  |  |  |  |  |
| 24264015M | CTOF Ready for Installation | milestone | 0d | 2015-08-05 | 2015-08-05 | 242231470M | 45d | 42d | 8/5 M-F w/JLAB Holidays ReBaseline |  |  | 24264015M | ELOUADRHIRI L | 1 | 1 | LATIFA E | 12-052 | 13-002 |  | 13-015 | PR |  |  | M |  |  |  |  |  |  |  |  |  |  |  |  |  |  |
| 24264882 | Install DC signal cable trays and gas lines |  | 35d | 2015-09-03 | 2015-10-22 | 24264915 FS+169d | 49d | 0d | 8/5 M-F w/JLAB Holidays ReBaseline | MECH TECH [640 h]; PROCUREMENT<$50K 60; PLABOR | 54,523.19 | 24264882 | ELOUADRHIRI L | 1 | 1 | LATIFA E | 12-052 | 13-002 | PE | 13-015 | PR | 14-001 | PE | S |  | 11 -035 | 12-024 | IN | 09-030 | 09-030 | 11-026 | ST | PE |  |  |  |  |  |
| 24264884 | Route DC Signal Cables |  | 35d | 2015-09-03 | 2015-10-22 | 24264882 FS-35d | 49d | 0d | 8/5 M-F w/JLAB Holidays ReBaseline | MECH TECH [480 h] | 22,713.6 | 24264884 | ELOUADRHIRI L | 1 | 1 | LATIFA E | 12-052 | 13-002 | PE | 13-015 | PR | 14-001 |  | S |  | 11 -035 | 12-024 | IN | 09-030 | 09-030 | 11-026 | ST |  |  |  |  |  |  |
| 24264006LOE | Installation Engineering Oversight FY16 |  | 77d | 2015-09-30 | 2016-01-28 | 24264005LOE | 420d | 479d | 8/5 M-F w/JLAB Holidays ReBaseline | SR STAFF [930 h]; MECH ENG [530 h] | 151,472.7 | 24264006LOE | ELOUADRHIRI L | 1 | 1 | LATIFA E |  |  | PE | 13-015 | PR | 14-001 |  | E |  | 11 -035 |  |  | 09-030 | 09-030 | 11-026 |  |  |  |  |  |  |  |
| 24264788M | Torus Assembled and Tested | milestone | 0d | 2015-10-01 | 2015-10-01 | 242743120, 28226015, 242743115, 242711.2005, 242743125 | 17d | 0d | 8/5 M-F w/JLAB Holidays ReBaseline |  |  | 24264788M | ELOUADRHIRI L | 1 | 1 | LATIFA E | 12-052 | 13-002 |  | 13-015 | PR |  |  | M | 13-010 | 11 -035 | 12-024 |  | 09-030 | 09-030 | 11-026 |  |  |  |  |  |  |  |
| 24264960M | Start Installation of Drift Chambers | milestone | 0d | 2015-10-01 | 2015-10-01 | 24264765, 3P-26M, 24264025M, 24264880, 24264886, 24264770, 24264890, 24264935, 24264930, 24264900, 24264788M | 17d | 0d | 8/5 M-F w/JLAB Holidays ReBaseline |  |  | 24264960M | ELOUADRHIRI L | 1 | 1 | LATIFA E | 12-052 | 13-002 |  | 13-015 | PR |  |  | M | 13-010 | 11 -035 | 12-024 | IN | 09-030 | 09-030 | 11-026 |  |  | 08-016 | 09-012 |  |  |  |
| 24264845 | Mount, assemble and cable CTOF system |  | 25d | 2015-10-05 | 2015-11-06 | 24264805, 28226025, 24264015M | 3d | 0d | 8/5 M-F w/JLAB Holidays ReBaseline | SCIENTIST [80 h]; MECH TECH [320 h] | 21,156.8 | 24264845 | ELOUADRHIRI L | 1 | 1 | LATIFA E | 12-052 | 13-002 | PE | 13-015 | PR | 14-001 |  | S | 13-010 | 11 -035 | 12-024 | IN | 09-030 | 09-030 | 11-026 | ST |  |  |  | 10-005 | 11-022 |  |
| 24264965 | Install Region 2 Drift Chamber |  | 10d | 2015-10-09 | 2015-10-22 | 28226015, 24264025M, 28226010, 24264960M FS+6d | 17d | 0d | 8/5 M-F w/JLAB Holidays ReBaseline | MECH TECH [544 h] | 25,742.08 | 24264965 | ELOUADRHIRI L | 1 | 1 | LATIFA E | 12-052 | 13-002 | PE | 13-015 | PR | 14-001 |  | S | 13-010 |  |  |  |  |  |  | ST |  |  |  |  |  |  |
| 24264970 | Survey/align R2 Drift chambers |  | 5d | 2015-10-16 | 2015-10-22 | 24264965 FS-5d | 17d | 0d | 8/5 M-F w/JLAB Holidays ReBaseline | MECH TECH [240 h] | 11,356.8 | 24264970 | ELOUADRHIRI L | 1 | 1 | LATIFA E | 12-052 | 13-002 | PE | 13-015 | PR | 14-001 |  | S | 13-010 |  |  |  |  |  |  | ST |  |  |  |  |  |  |
| 24264975 | Install Region 1 Drift Chamber |  | 10d | 2015-10-22 | 2015-11-04 | 28226015, 24264960M, 24264970 FS-1d, 28226010, 24264030M | 17d | 0d | 8/5 M-F w/JLAB Holidays ReBaseline | MECH TECH [544 h] | 25,742.08 | 24264975 | ELOUADRHIRI L | 1 | 1 | LATIFA E | 12-052 | 13-002 | PE | 13-015 | PR | 14-001 |  | S | 13-010 |  |  |  |  |  |  | ST |  |  |  |  |  |  |
| 24264980 | Survey/align R1 Drift chambers |  | 5d | 2015-10-27 | 2015-11-02 | 24264975 FS-7d | 17d | 0d | 8/5 M-F w/JLAB Holidays ReBaseline | MECH TECH [240 h] | 11,356.8 | 24264980 | ELOUADRHIRI L | 1 | 1 | LATIFA E | 12-052 | 13-002 | PE | 13-015 | PR | 14-001 |  | S | 13-010 |  |  |  |  |  |  | ST |  |  |  |  |  |  |
| 24264985 | Install Region 3 Drift Chamber |  | 10d | 2015-11-02 | 2015-11-13 | 28226010, 28226015, 24264980 FS-1d, 24264020M, 24264960M | 17d | 0d | 8/5 M-F w/JLAB Holidays ReBaseline | MECH TECH [544 h] | 25,742.08 | 24264985 | ELOUADRHIRI L | 1 | 1 | LATIFA E | 12-052 | 13-002 | PE | 13-015 | PR | 14-001 |  | S | 13-010 |  |  |  |  |  |  | ST |  |  |  |  |  |  |
| 24264870 | Rig and Transport HTCC to Hall |  | 2d | 2015-11-03 | 2015-11-04 | 24264080M, 24264980 | 20d | 0d | 8/5 M-F w/JLAB Holidays ReBaseline | MECH TECH [40 h] | 1,892.8 | 24264870 | ELOUADRHIRI L | 1 | 1 | LATIFA E | 12-052 | 13-002 | PE | 13-015 | PR | 14-001 |  | H | 13-010 | 11 -035 | 12-024 | IN | 09-030 | 09-030 | 11-026 |  |  |  |  |  | 11-022 | 12-007 |
| 24264872 | Install HTCC cart |  | 4d | 2015-11-05 | 2015-11-10 | 24264160, 24264868, 24264870 | 20d | 0d | 8/5 M-F w/JLAB Holidays ReBaseline | MECH TECH [20 h] | 946.4 | 24264872 | ELOUADRHIRI L | 1 | 1 | LATIFA E | 12-052 | 13-002 | PE | 13-015 | PR | 14-001 |  | H | 13-010 | 11 -035 | 12-024 |  |  |  |  |  |  |  |  |  |  | 12-007 |
| 24264990 | Survey/align R3 Drift chambers |  | 5d | 2015-11-06 | 2015-11-12 | 24264985 FS-6d | 17d | 0d | 8/5 M-F w/JLAB Holidays ReBaseline | MECH TECH [240 h] | 11,356.8 | 24264990 | ELOUADRHIRI L | 1 | 1 | LATIFA E | 12-052 | 13-002 | PE | 13-015 | PR | 14-001 |  | S | 13-010 |  |  |  |  |  |  | ST |  |  |  |  |  |  |
| 24264850 | Align CTOF |  | 5d | 2015-11-09 | 2015-11-13 | 24264845 | 3d | 0d | 8/5 M-F w/JLAB Holidays ReBaseline | MECH TECH [48 h] | 2,271.36 | 24264850 | ELOUADRHIRI L | 1 | 1 | LATIFA E | 12-052 | 13-002 | PE | 13-015 | PR | 14-001 |  | H | 13-010 | 11 -035 | 12-024 |  |  |  |  |  |  |  |  |  |  |  |
| 24264874 | Install HTCC |  | 2d | 2015-11-11 | 2015-11-12 | 28226020 FS-20d, 24264872 | 20d | 0d | 8/5 M-F w/JLAB Holidays ReBaseline | MECH TECH [120 h] | 5,678.4 | 24264874 | ELOUADRHIRI L | 1 | 1 | LATIFA E | 12-052 | 13-002 | PE | 13-015 | PR | 14-001 |  | H | 13-010 | 11 -035 | 12-024 |  |  |  |  |  |  |  |  |  |  | 12-007 |
| 24264855 | Mount, cable and check SVT system |  | 15d | 2015-11-13 | 2015-12-07 | 24264850 FS-1d, 24264010M | 3d | 0d | 8/5 M-F w/JLAB Holidays ReBaseline | MECH TECH [320 h]; SCIENTIST [80 h] | 21,156.8 | 24264855 | ELOUADRHIRI L | 1 | 1 | LATIFA E | 12-052 | 13-002 | PE | 13-015 | PR | 14-001 |  | S | 13-010 | 11 -035 | 12-024 |  |  |  |  | ST |  |  |  |  |  |  |
| 24264876 | HTCC verify mirror alignment and align detector to beam |  | 3d | 2015-11-13 | 2015-11-17 | 24264874 | 20d | 0d | 8/5 M-F w/JLAB Holidays ReBaseline | MECH TECH [48 h]; SCIENTIST [48 h] | 5,880 | 24264876 | ELOUADRHIRI L | 1 | 1 | LATIFA E | 12-052 | 13-002 | PE | 13-015 | PR | 14-001 |  | H | 13-010 | 11 -035 | 12-024 |  |  |  |  |  |  |  |  |  |  | 12-007 |
| 24264995 | Connect / Cable Drift Chambers |  | 10d | 2015-11-13 | 2015-11-30 | 24264990 | 17d | 14d | 8/5 M-F w/JLAB Holidays ReBaseline | ELEC TECH [80 h]; SCIENTIST [80 h] | 9,773.6 | 24264995 | ELOUADRHIRI L | 1 | 1 | LATIFA E | 12-052 | 13-002 | PE | 13-015 | PR | 14-001 |  | H | 13-010 |  |  |  |  |  |  |  |  |  |  |  |  |  |
| 24264878 | Cable HTCC |  | 4d | 2015-11-18 | 2015-11-23 | 24264876 | 20d | 17d | 8/5 M-F w/JLAB Holidays ReBaseline | MECH TECH [32 h] | 1,514.24 | 24264878 | ELOUADRHIRI L | 1 | 1 | LATIFA E | 12-052 | 13-002 | PE | 13-015 | PR | 14-001 |  | H | 13-010 | 11 -035 | 12-024 |  |  |  |  |  |  |  |  |  |  | 12-007 |
| 24264860 | Align SVT |  | 10d | 2015-12-07 | 2015-12-18 | 24264855 FS-1d | 3d | 0d | 8/5 M-F w/JLAB Holidays ReBaseline | MECH TECH [48 h] | 2,271.36 | 24264860 | ELOUADRHIRI L | 1 | 1 | LATIFA E | 12-052 | 13-002 | PE | 13-015 | PR | 14-001 |  | H | 13-010 | 11 -035 | 12-024 |  |  |  |  |  |  |  |  |  |  |  |
| 24264860M | Central Detector Ready | milestone | 0d | 2015-12-18 | 2015-12-18 | 24264850, 24264125, 24264860 | 3d | 0d | 8/5 M-F w/JLAB Holidays ReBaseline |  |  | 24264860M | ELOUADRHIRI L | 1 | 1 | LATIFA E | 12-052 | 13-002 |  | 13-015 | PR |  |  | M | 13-010 |  |  |  |  |  |  |  |  |  |  |  |  |  |

Notes:
- 24264882: Steps: Connect cables to R1 cable trays; Install R1 cable trays; Connect cables to R3 cable trays; Install R3 cable trays; Install cable trays on Torus; Install gas lines
- 24264884: Steps: Route cables for region 1; Route cables for region 2; Route cables for region 3
- 24264845: Steps: Install CTOF support structure to solenoid; Install 48 counters; Install 96 magnetic shields; Cable detector
- 24264965: Steps: Install Region 2 Drift Chamber Sector 1; Install Region 2 Drift Chamber Sector 2; Install Region 2 Drift Chamber Sector 3; Install Region 2 Drift Chamber Sector 4; Install Region 2 Drift Chamber Sector 5; Install Region 2 Drift Chamber Sector 6
- 24264970: Steps: Survey/align R2 Drift chambers Sector 1; Survey/align R2 Drift chambers Sector 2; Survey/align R2 Drift chambers Sector 3; Survey/align R2 Drift chambers Sector 4; Survey/align R2 Drift chambers Sector 5; Survey/align R2 Drift chambers Sector 6
- 24264975: Steps: Install Region 1 Drift Chamber Sector 1; Install Region 1 Drift Chamber Sector 2; Install Region 1 Drift Chamber Sector 3; Install Region 1 Drift Chamber Sector 4; Install Region 1 Drift Chamber Sector 5; Install Region 1 Drift Chamber Sector 6
- 24264980: Steps: Survey/align R1 Drift chambers Sector 1; Survey/align R1 Drift chambers Sector 2; Survey/align R1 Drift chambers Sector 3; Survey/align R1 Drift chambers Sector 4; Survey/align R1 Drift chambers Sector 5; Survey/align R1 Drift chambers Sector 6
- 24264985: Steps: Install Region 3 Drift Chamber Sector 1; Install Region 3 Drift Chamber Sector 2; Install Region 3 Drift Chamber Sector 3; Install Region 3 Drift Chamber Sector 4; Install Region 3 Drift Chamber Sector 5; Install Region 3 Drift Chamber Sector 6
- 24264990: Steps: Survey/align R3 Drift chambers Sector 1; Survey/align R3 Drift chambers Sector 2; Survey/align R3 Drift chambers Sector 3; Survey/align R3 Drift chambers Sector 4; Survey/align R3 Drift chambers Sector 5; Survey/align R3 Drift chambers Sector 6
- 24264855: Steps: Install SVT cart; Install SVT electronics; Place SVT on cart

| ID | WBS | Activity | Type | Duration | Start | Finish | Predecessors | Total float | Free float | Calendar | Resources | Cost | RESP - Responsibility | STRT%COMP for CM EVM | FNSH%COMP for CM EVM | CAM RESPONSIBLE | 12 GEV MAJOR PROCUREMENT CATAGORY | CR 12-011 | CR 12-024 | CR 13-002 | CR 13-005 | CR 12-042 | CR 13-014 | ReBaseline Actuals Adjustment | Original Activity ID Rebaseline | Over Under Fixed | EVMS Reporting Codes | BOE Procurement | CR 13-015 | Post Rebaseline | Obligated Prior to Rebaseline | BOE Labor | CR 14-001 |
| --- | --- | --- | --- | --- | --- | --- | --- | --- | --- | --- | --- | --- | --- | --- | --- | --- | --- | --- | --- | --- | --- | --- | --- | --- | --- | --- | --- | --- | --- | --- | --- | --- | --- |
|  | 7 | **1.4.2.7 HALL B MAGNETS** |  |  | 2011-12-01 | 2015-09-30 |  |  |  |  |  |  |  |  |  |  |  |  |  |  |  |  |  |  |  |  |  |  |  |  |  |  |  |
|  | 1 | **1.4.2.7.1 TOROIDAL MAGNET NEW VENDOR** |  |  | 2011-12-01 | 2014-09-30 |  |  |  |  |  |  |  |  |  |  |  |  |  |  |  |  |  |  |  |  |  |  |  |  |  |  |  |
| 14271000 |  | Procure Replacement Copper |  | 40d | 2011-12-01 | 2012-02-03 | 9-120M FS+41d | 662d |  |  | PROCUREMENT<$50K 60 | 20,000 | ELOUADRHIRI L | 1 | 1 | LATIFA E | 4211 | 12-011 | 12-024F | 13-002F |  |  |  |  |  |  |  |  |  |  |  |  |  |
| 14271005 |  | JLab Design and Support Labor FY12 |  | 84d | 2012-06-01 | 2012-09-28 | 9-120M FS+163d | 397d | 0d |  | MECH ENG [1273.33 h] | 89,285.9 | ELOUADRHIRI L | 1 | 1 | LATIFA E | 4211 |  | 12-024 | 13-002F | 13-005F |  |  |  |  |  |  |  |  |  |  |  |  |
| 14271015 |  | FNAL: Kickoff Meeting |  | 2d | 2012-06-01 | 2012-06-05 | 9-120M FS+163d | 20d | 0d |  | PROCUREMENT<$50K 60 NO ESCALATION | 2,416 | ELOUADRHIRI L | 1 | 1 | LATIFA E | 4211 |  | 12-024 | 13-002F |  | 12-042 |  |  |  |  |  |  |  |  |  |  |  |
| 14271020 |  | FNAL: Discussions on Manufacturing possibilities |  | 11d | 2012-06-01 | 2012-06-18 | 14273003 FS-86d, 14273012 FS-270d, 14273010 FS-86d, 14271015 FS-2d, 14273014B FS-135d, 9-120M FS+77d, 14273010K FS-270d | 20d | 0d |  | PROCUREMENT<$50K 60 NO ESCALATION | 24,160 | ELOUADRHIRI L | 1 | 1 | LATIFA E | 4211 |  | 12-024 | 13-002F |  | 12-042 |  |  |  |  |  |  |  |  |  |  |  |
| 14271025 |  | FNAL: Acceptance of Proposal for fabrication |  | 12d | 2012-06-01 | 2012-06-19 | 14271020 FS-11d | 20d | 0d |  | PROCUREMENT<$50K 60 NO ESCALATION | 2,416 | ELOUADRHIRI L | 1 | 1 | LATIFA E | 4211 |  | 12-024 | 13-002F |  | 12-042 |  |  |  |  |  |  |  |  |  |  |  |
| 14271025A |  | FNAL: Overview of Wang NMR CCM Design |  | 12d | 2012-06-01 | 2012-06-19 | 14271025 FS-12d | 20d | 0d |  | PROCUREMENT<$50K 60 NO ESCALATION; PROCUREMENT>$50K 69 NO ESCALATION | 26,576 | ELOUADRHIRI L | 1 | 1 | LATIFA E | 4211 |  |  | 13-002F |  | 12-042 |  |  |  |  |  |  |  |  |  |  |  |
| 14271025B |  | FNAL: Develop CCM fabrication and QA/QC plans |  | 33d | 2012-06-01 | 2012-07-18 | 14271025A FS-12d | 20d | 0d |  | PROCUREMENT>$50K 69 NO ESCALATION | 48,320 | ELOUADRHIRI L | 1 | 1 | LATIFA E | 4211 |  |  | 13-002F |  | 12-042 |  |  |  |  |  |  |  |  |  |  |  |
| 14271025C |  | FNAL: Design of CCM Tooling |  | 65d | 2012-06-01 | 2012-08-31 | 14271025B FS-33d | 20d | 0d |  | PROCUREMENT>$50K 69 NO ESCALATION | 106,304 | ELOUADRHIRI L | 1 | 1 | LATIFA E | 4211 |  |  | 13-002F |  | 12-042 |  |  |  |  |  |  |  |  |  |  |  |
| 14271025D |  | FNAL: Tooling Installation at FNAL |  | 84d | 2012-06-01 | 2012-09-28 | 14271025C FS-65d, 14271026 FS-90d | 20d | 0d |  | PROCUREMENT>$50K 69 NO ESCALATION | 24,160 | ELOUADRHIRI L | 1 | 1 | LATIFA E | 4211 |  |  | 13-002F |  | 12-042 |  |  |  |  |  |  |  |  |  |  |  |
| 14271025F |  | FNAL: Manufacturing Readiness Review |  | 84d | 2012-06-01 | 2012-09-28 | 14271025D FS-84d | 20d | 0d |  | PROCUREMENT>$50K 69 NO ESCALATION | 4,832 | ELOUADRHIRI L | 1 | 1 | LATIFA E | 4211 |  |  | 13-002F |  | 12-042 |  |  |  |  |  |  |  |  |  |  |  |
| 14271025G |  | FNAL: Prototype CCM winding and tests |  | 143d | 2012-06-01 | 2012-12-31 | 14271025F FS-84d | 20d | 0d |  | PROCUREMENT>$50K 69 NO ESCALATION | 144,960 | ELOUADRHIRI L | 1 | 1 | LATIFA E | 4211 |  |  | 13-002F |  | 12-042 |  |  |  |  |  |  |  |  |  |  |  |
| 14271025H |  | FNAL: Update design with lessons learned from prototype |  | 164d | 2012-06-01 | 2013-01-31 | 14271025G FS-143d | 20d | 0d |  | PROCUREMENT>$50K 69 NO ESCALATION | 60,400 | ELOUADRHIRI L | 1 | 1 | LATIFA E | 4211 |  |  | 13-002F |  | 12-042 |  |  |  |  |  |  |  |  |  |  |  |
| 14271025J |  | FNAL: Production CCM readiness review |  | 164d | 2012-06-01 | 2013-01-31 | 14271025H FS-164d | 20d | 0d |  | PROCUREMENT>$50K 69 NO ESCALATION | 2,416 | ELOUADRHIRI L | 1 | 1 | LATIFA E | 4211 |  |  | 13-002F |  | 12-042 |  |  |  |  |  |  |  |  |  |  |  |
| 14271025K |  | FNAL: Production final CCM#1 and test |  | 226d | 2012-06-01 | 2013-04-30 | 14271025J FS-164d | 20d | 0d |  | PROCUREMENT>$50K 69 NO ESCALATION | 114,336 | ELOUADRHIRI L | 1 | 1 | LATIFA E | 4211 |  |  | 13-002F |  | 12-042 |  |  |  |  |  |  |  |  |  |  |  |
| 14271025L |  | FNAL: Production final CCM#2 and test |  | 248d | 2012-06-01 | 2013-05-31 | 14271025K FS-226d | 20d | 0d |  | PROCUREMENT>$50K 69 NO ESCALATION | 104,898 | ELOUADRHIRI L | 1 | 1 | LATIFA E | 4211 |  |  | 13-002F |  | 12-042 |  |  |  |  |  |  |  |  |  |  |  |
| 14271025N |  | FNAL: Production final CCM#3 and test |  | 290d | 2012-06-01 | 2013-07-31 | 14271025L FS-248d | 20d | 0d |  | PROCUREMENT>$50K 69 NO ESCALATION | 102,426 | ELOUADRHIRI L | 1 | 1 | LATIFA E | 4211 |  |  | 13-002F |  | 12-042 |  |  |  |  |  |  |  |  |  |  |  |
| 14271025P |  | FNAL: Production final CCM#4 and test |  | 290d | 2012-06-01 | 2013-07-31 | 14271025N FS-290d | 20d | 0d |  | PROCUREMENT>$50K 69 NO ESCALATION | 71,460 | ELOUADRHIRI L | 1 | 1 | LATIFA E | 4211 |  |  | 13-002F |  | 12-042 |  |  |  |  |  |  |  |  |  |  |  |
| 14271025Q |  | FNAL: Production final CCM#5 and test |  | 312d | 2012-06-01 | 2013-08-30 | 14271025P FS-290d | 20d |  |  | PROCUREMENT>$50K 69 NO ESCALATION | 71,460 | ELOUADRHIRI L | 1 | 1 | LATIFA E | 4211 |  |  | 13-002F |  | 12-042 |  |  |  |  |  |  |  |  |  |  |  |
| 14271027LOE |  | JLab support of FNAL Torus CCM effort FY12 |  | 84d | 2012-06-01 | 2012-09-28 | 9-120M FS+163d | 573d | 0d |  | MECH DES [560.07 h]; MECH ENG [560.1 h] | 66,252.78 | ELOUADRHIRI L | 1 | 1 | LATIFA E | 4211 |  |  | 13-002F | 13-005F | 12-042 |  |  |  |  |  |  |  |  |  |  |  |
| 14271026 |  | JLab Fabrication of Tooling |  | 70d | 2012-06-22 | 2012-09-28 | 9-120M FS+177d | 26d | 6d |  | PROCUREMENT>$50K 69; PROCUREMENT<$50K 60; MSHOP | 328,571.4 | ELOUADRHIRI L | 1 | 1 | LATIFA E | 4211 |  |  | 13-002F |  | 12-042 |  |  |  |  |  |  |  |  |  |  |  |
| 14271010 |  | JLab Design and Support Labor FY13 Original |  | 59d | 2012-10-01 | 2012-12-31 | 14271005 | 397d | 0d |  | MECH ENG [587.13 h] | 42,484.73 | ELOUADRHIRI L | 1 | 1 | LATIFA E | 4211 |  | 12-024 | 13-002F | 13-005 |  |  |  |  |  |  |  |  |  |  |  |  |
| 14271028LOE |  | JLab support of FNAL Torus CCM effort FY13 Original |  | 59d | 2012-10-01 | 2012-12-31 | 14271027LOE | 573d | 0d |  | MECH ENG [393.4 h]; MECH DES [393.39 h] | 48,021.84 | ELOUADRHIRI L | 1 | 1 | LATIFA E | 4211 |  |  | 13-002F | 13-005 | 12-042 |  |  |  |  |  |  |  |  |  |  |  |
| 14271030 |  | Machine Shop Effort FY13 |  | 228d | 2012-10-01 | 2013-08-30 | 9-130M | 20d |  |  | MSHOP | 246,255.71 | ELOUADRHIRI L | 1 | 1 | LATIFA E | 4211 |  | 12-024 | 13-002F |  |  | 13-014 |  |  |  |  |  |  |  |  |  |  |
| 14271012 |  | JLab Design and Support Labor FY13 Revised |  | 40d | 2013-01-02 | 2013-02-28 | 14271010 | 397d |  |  | MECH ENG [2224 h]; MECH TECH [784 h]; MECH DES [1824 h]; ELEC ENG [864 h]; PLABOR | 400,986.81 | ELOUADRHIRI L | 1 | 1 | LATIFA E | 4211 |  | 12-024 | 13-002F | 13-005 |  |  |  |  |  |  |  |  |  |  |  |  |
| 14271028LOEA |  | JLab support of FNAL Torus CCM effort FY13 Revised |  | 169d | 2013-01-02 | 2013-08-30 | 14271028LOE | 573d | 570d |  | MECH ENG [1180.32 h]; MECH DES [1180.32 h] | 144,081.05 | ELOUADRHIRI L | 1 | 1 | LATIFA E | 4211 |  | 12-024 | 13-002F | 13-005 |  | 13-014 |  |  |  |  |  |  |  |  |  |  |
| 14271040 |  | Cryostat Factory Phase 1 |  | 60d | 2013-01-03 | 2013-03-29 | 9-130M FS+60d | 20d | 0d |  | MECH ENG [1850.95 h]; MECH DES [1347.19 h]; MECH TECH [1460.26 h] | 267,871.07 | ELOUADRHIRI L | 1 | 1 | LATIFA E | 4211 |  | 12-024 | 13-002F |  |  |  |  |  |  |  |  |  |  |  |  |  |
| 14271045 |  | Cryostat Factory Phase 2 |  | 108d | 2013-04-01 | 2013-08-30 | 14271040 | 20d |  |  | MECH TECH [7885.43 h]; MECH ENG [1249.39 h] | 452,031.72 | ELOUADRHIRI L | 1 | 1 | LATIFA E | 4211 | 12-011 | 12-024 | 13-002F |  |  | 13-014 |  |  |  |  |  |  |  |  |  |  |
| 14271085 |  | Re-Baseline Actuals Adjustment |  | 1d | 2013-08-30 | 2013-08-30 | 9-130M FS+227d | 20d |  |  | PROCUREMENT>$50K 69 NO ESCALATION | 558,132.32 | ELOUADRHIRI L | 1 | 1 | LATIFA E |  |  |  |  |  |  | 13-014 | ADJ |  |  |  |  |  |  |  |  |  |
| 24271665 |  | FNAL: Tooling Fabrication and Installation at FNAL Part B |  | 10d | 2013-09-03 | 2013-09-16 | 9-130M FS+228d | 20d | 0d | 8/5 M-F w/JLAB Holidays ReBaseline | PROCUREMENT<$50K 60 | 2,467.22 | ELOUADRHIRI L | 1 | 1 | LATIFA E | 4211 |  |  | 13-002F |  | 12-042 |  |  | 24271665 | y | D | VQ | 13-015 | PR | OB |  |  |
| 24271680 |  | FNAL: Prototype CCM winding and tests |  | 35d | 2013-09-03 | 2013-10-21 | 24271665 FS-10d, 242751020 FS-80d | 20d | 0d | 8/5 M-F w/JLAB Holidays ReBaseline | PROCUREMENT<$50K 60 NO ESCALATION | 35,234.21 | ELOUADRHIRI L | 1 | 1 | LATIFA E | 4211 |  |  | 13-002F |  | 12-042 |  |  | 24271680 | y | D | VQ | 13-015 | PR | OB |  |  |
| 24271685 |  | FNAL: Update design with lessons learned from prototype |  | 62d | 2013-09-03 | 2013-11-27 | 24271680 FS-35d | 20d | 0d | 8/5 M-F w/JLAB Holidays ReBaseline | PROCUREMENT<$50K 60 NO ESCALATION; PROCUREMENT>$50K 69 NO ESCALATION | 46,566.63 | ELOUADRHIRI L | 1 | 1 | LATIFA E | 4211 |  |  | 13-002F |  | 12-042 |  |  | 24271685 | y | D | VQ | 13-015 | PR | OB |  |  |
| 24271690 |  | FNAL: Production CCM readiness review |  | 62d | 2013-09-03 | 2013-11-27 | 24271685 FS-62d | 20d | 0d | 8/5 M-F w/JLAB Holidays ReBaseline | PROCUREMENT>$50K 69 NO ESCALATION | 24,835.54 | ELOUADRHIRI L | 1 | 1 | LATIFA E | 4211 |  |  | 13-002F |  | 12-042 |  |  | 24271690 | y | D | VQ | 13-015 | PR | OB |  |  |
| 24271695 |  | FNAL: Production final CCM#1 and test |  | 161d | 2013-09-03 | 2014-04-30 | 24271690 FS-62d, 242751045 FS-139d | 20d | 0d | 8/5 M-F w/JLAB Holidays ReBaseline | PROCUREMENT>$50K 69 NO ESCALATION | 133,482.97 | ELOUADRHIRI L | 1 | 1 | LATIFA E | 4211 |  |  | 13-002F |  | 12-042 |  |  | 24271695 | y | D | VQ | 13-015 | PR | OB |  |  |
| 24271725 LOE |  | Consultant Fees WS LQ |  | 267d | 2013-09-03 | 2014-09-30 | 9-130M FS+228d | 304d | 301d | 8/5 M-F w/JLAB Holidays ReBaseline | PROCUREMENT<$50K 60 NO ESCALATION FY14 | 22,950 | ELOUADRHIRI L | 1 | 1 | LATIFA E | 4211 |  |  | 13-002F |  | 12-042 |  |  | 24271720 | y | D | VQ | 13-015 | PR | OB |  |  |
| 24271730 |  | Existing Coil Case Storage |  | 267d | 2013-09-03 | 2014-09-30 | 9-130M FS+228d | 304d | 301d | 8/5 M-F w/JLAB Holidays ReBaseline | PROCUREMENT<$50K 60 NO ESCALATION FY14 | 2,106 | ELOUADRHIRI L | 1 | 1 | LATIFA E | 4211 |  |  | 13-002F |  | 12-042 |  |  | 24271720 | y | D | VQ | 13-015 | PR | OB |  |  |
| 24271730LOE |  | JLab support of FNAL Torus CCM effort FY13 |  | 20d | 2013-09-03 | 2013-09-30 | 9-130M FS+228d | 72d | 0d | 8/5 M-F w/JLAB Holidays ReBaseline | SR STAFF [137.58 h] | 16,041.83 | ELOUADRHIRI L | 1 | 1 | LATIFA E | 4211 |  | 12-024 | 13-002F | 13-005 |  |  |  | 24271730LOE |  | E |  | 13-015 | PR |  | EJ |  |
| 24271735 |  | Contractor Training TW |  | 267d | 2013-09-03 | 2014-09-30 | 9-130M FS+228d | 304d | 301d | 8/5 M-F w/JLAB Holidays ReBaseline | PROCUREMENT<$50K 60 NO ESCALATION FY14 | 266.4 | ELOUADRHIRI L | 1 | 1 | LATIFA E | 4211 |  |  | 13-002F |  | 12-042 |  |  | 24271720 | y | D | VQ | 13-015 | PR | OB |  |  |
| 24271740 |  | Additional Torus Copper Stabilizer and SSC Cable tests for Coil #7 |  | 60d | 2013-09-03 | 2013-11-25 | 9-130M FS+228d | 58d | 0d | 8/5 M-F w/JLAB Holidays ReBaseline | PROCUREMENT<$50K 60 NO ESCALATION FY14 | 24,035 | ELOUADRHIRI L | 1 | 1 | LATIFA E | 4211 |  | 12-024 | 13-002F |  |  |  |  | 24272180 | y | D |  | 13-015 | PR | OB | EJ |  |
| 24271700 |  | FNAL: Production final CCM#2 and test |  | 162d | 2013-10-01 | 2014-05-30 | 24271695 FS-161d, 9-140M | 0d |  | 8/5 M-F w/JLAB Holidays ReBaseline | PROCUREMENT<$50K 60 NO ESCALATION; PROCUREMENT>$50K 69 NO ESCALATION | 123,134.83 | ELOUADRHIRI L | 1 | 1 | LATIFA E | 4211 |  |  | 13-002F |  | 12-042 |  |  | 24271700 |  | D | VQ | 13-015 | PR |  |  |  |
| 24271705 |  | FNAL: Production final CCM#3 and test |  | 183d | 2013-10-01 | 2014-06-30 | 24271700 FS-162d | 0d |  | 8/5 M-F w/JLAB Holidays ReBaseline | PROCUREMENT>$50K 69 NO ESCALATION | 123,134.83 | ELOUADRHIRI L | 1 | 1 | LATIFA E | 4211 |  |  | 13-002F |  | 12-042 |  |  | 24271705 |  | D | VQ | 13-015 | PR |  |  |  |
| 24271710 |  | FNAL: Production final CCM#4 and test |  | 205d | 2013-10-01 | 2014-07-31 | 24271705 FS-183d | 0d |  | 8/5 M-F w/JLAB Holidays ReBaseline | PROCUREMENT>$50K 69 NO ESCALATION | 123,134.83 | ELOUADRHIRI L | 1 | 1 | LATIFA E | 4211 |  |  | 13-002F |  | 12-042 |  |  | 24271710 |  | D | VQ | 13-015 | PR |  |  |  |
| 24271715 |  | FNAL: Production final CCM#5 and test |  | 226d | 2013-10-01 | 2014-08-29 | 24271710 FS-205d | 0d |  | 8/5 M-F w/JLAB Holidays ReBaseline | PROCUREMENT>$50K 69 NO ESCALATION | 123,134.83 | ELOUADRHIRI L | 1 | 1 | LATIFA E | 4211 |  |  | 13-002F |  | 12-042 |  |  | 24271715 |  | D | VQ | 13-015 | PR |  |  |  |
| 24271720 |  | FNAL: Production final CCM#6 and test |  | 247d | 2013-10-01 | 2014-09-30 | 24271715 FS-226d | 0d |  | 8/5 M-F w/JLAB Holidays ReBaseline | PROCUREMENT>$50K 69 NO ESCALATION | 123,134.83 | ELOUADRHIRI L | 1 | 1 | LATIFA E | 4211 |  |  | 13-002F |  | 12-042 |  |  | 24271720 |  | D | VQ | 13-015 | PR |  |  |  |
| 24271735LOE |  | JLab support of FNAL Torus CCM effort FY14 |  | 184d | 2013-10-01 | 2014-07-01 | 24271730LOE | 72d | 0d | 8/5 M-F w/JLAB Holidays ReBaseline | SR STAFF [1266 h] | 152,325.12 | ELOUADRHIRI L | 1 | 1 | LATIFA E | 4211 |  | 12-024 | 13-002F | 13-005 |  |  |  | 24271735LOE |  | E |  | 13-015 | PR |  | EJ | 14-001 |
| 24271740M |  | FNAL Torus work complete | milestone | 0d | 2014-09-30 | 2014-09-30 | 24271720 | 0d |  | 8/5 M-F w/JLAB Holidays ReBaseline |  |  | ELOUADRHIRI L | 1 | 1 | LATIFA E | 4211 |  |  | 13-002F |  | 12-042 |  |  | 24271740M |  | M |  | 13-015 | PR |  |  |  |

| ID | WBS | Activity | Type | Duration | Start | Finish | Predecessors | Total float | Free float | Calendar | Resources | Cost | RESP - Responsibility | STRT%COMP for CM EVM | FNSH%COMP for CM EVM | CAM RESPONSIBLE | 12 GEV MAJOR PROCUREMENT CATAGORY | CR 12-024 | CR 13-002 | CR 13-014 | CR 13-004 | CR 13-008 | CR 12-054 | ReBaseline Actuals Adjustment | Original Activity ID Rebaseline | Over Under Fixed | EVMS Reporting Codes | BOE Procurement | CR 13-015 | Post Rebaseline | Obligated Prior to Rebaseline | CR 14-001 |
| --- | --- | --- | --- | --- | --- | --- | --- | --- | --- | --- | --- | --- | --- | --- | --- | --- | --- | --- | --- | --- | --- | --- | --- | --- | --- | --- | --- | --- | --- | --- | --- | --- |
|  | 2 | **1.4.2.7.2 SOLENOID MAGNET NEW VENDOR** |  |  | 2012-06-01 | 2015-09-30 |  |  |  |  |  |  |  |  |  |  |  |  |  |  |  |  |  |  |  |  |  |  |  |  |  |  |
| 14271055 |  | JLab Design and Support Labor FY12 |  | 84d | 2012-06-01 | 2012-09-28 | 9-120M FS+163d | 20d | 0d |  | MECH ENG [1273.33 h] | 89,285.9 | ELOUADRHIRI L | 1 | 1 | LATIFA E | 4211 | 12-024 | 13-002F |  |  |  |  |  |  |  |  |  |  |  |  |  |
| 14271060 |  | JLab Design and Support Labor FY13 |  | 228d | 2012-10-01 | 2013-08-30 | 14271055 | 20d |  |  | MECH ENG [567.22 h] | 41,044.04 | ELOUADRHIRI L | 1 | 1 | LATIFA E | 4211 | 12-024 | 13-002F | 13-014 |  |  |  |  |  |  |  |  |  |  |  |  |
| 14271068M |  | Award Solenoid Contract | milestone | 0d | 2012-11-27 | 2012-11-27 | 9-130M FS+39d | 20d | 0d |  |  |  | ELOUADRHIRI L | 1 | 1 | LATIFA E | 4211 |  |  |  | 13-004 |  |  |  |  |  |  |  |  |  |  |  |
| 14271070 |  | Vend Fab Solenoid - Peg Point #1 - Preliminary Design Review |  | 81d | 2012-11-27 | 2013-03-29 | 14271068M | 20d | 0d |  | PROCUREMENT<$50K 60 NO ESCALATION; PROCUREMENT>$50K 69 NO ESCALATION | 199,085 | ELOUADRHIRI L | 1 | 1 | LATIFA E | 4211 | 12-024 |  |  | 13-004 |  |  |  |  |  |  |  |  |  |  |  |
| 14271075 |  | Vend Fab Solenoid - Peg Point #2 - Intermediate Design Review |  | 125d | 2012-11-27 | 2013-05-31 | 14271070 FS-81d | 20d | 0d |  | PROCUREMENT>$50K 69 NO ESCALATION | 99,543 | ELOUADRHIRI L | 1 | 1 | LATIFA E | 4211 | 12-024 |  |  | 13-004 | 13-008 |  |  |  |  |  |  |  |  |  |  |
| 14271075a |  | Vend Fab Solenoid - Peg Point #3 - Final Design Review |  | 145d | 2012-11-27 | 2013-06-28 | 14271075 FS-125d | 20d | 0d |  | PROCUREMENT>$50K 69 NO ESCALATION | 99,543 | ELOUADRHIRI L | 1 | 1 | LATIFA E | 4211 |  |  |  | 13-004 |  |  |  |  |  |  |  |  |  |  |  |
| 14271075c |  | Vend Fab Solenoid - Peg Point #4 - Winding and Potting Tooling |  | 189d | 2012-11-27 | 2013-08-30 | 14271075b FS-145d | 20d |  |  | PROCUREMENT>$50K 69 NO ESCALATION | 79,634 | ELOUADRHIRI L | 1 | 1 | LATIFA E | 4211 |  |  |  | 13-004 |  |  |  |  |  |  |  |  |  |  |  |
| 14271075b |  | Vend Fab Solenoid - Final Design Review Incetive Fee |  | 128d | 2012-12-20 | 2013-06-28 | 14271075a FS-128d | 20d | 0d |  | PROCUREMENT>$50K 69 NO ESCALATION | 200,000 | ELOUADRHIRI L | 1 | 1 | LATIFA E | 4211 |  |  |  | 13-004 |  |  |  |  |  |  |  |  |  |  |  |
| 14271080 |  | Machine Shop Effort |  | 128d | 2013-03-04 | 2013-08-30 | 9-130M FS+100d | 324d | 309d |  | MSHOP | 183,567.85 | ELOUADRHIRI L | 1 | 1 | LATIFA E | 4211 | 12-024 | 13-002F | 13-014 |  |  | 12-054 |  |  |  |  |  |  |  |  |  |
| 14271090 |  | Re-Baseline Actuals Adjustment |  | 1d | 2013-08-30 | 2013-08-30 | 9-130M FS+227d | 20d |  |  | PROCUREMENT>$50K 69 NO ESCALATION | -328,437.4 | ELOUADRHIRI L | 1 | 1 | LATIFA E |  |  |  | 13-014 |  |  |  | ADJ |  |  |  |  |  |  |  |  |
| 24272075 |  | Vend Fab Solenoid - Peg Point #2 - Intermediate Design Review |  | 43d | 2013-09-03 | 2013-10-31 | 9-130M FS+228d | 17d | 0d | 8/5 M-F w/JLAB Holidays ReBaseline | PROCUREMENT>$50K 69 NO ESCALATION | 49,771.5 | ELOUADRHIRI L | 1 | 1 | LATIFA E | 4211 | 12-024 |  |  | 13-004 | 13-008 |  |  | 24272075 | y | D | OB | 13-015 | PR | OB |  |
| 24272075a |  | Vend Fab Solenoid - Peg Point #3 - Final Design Review |  | 77d | 2013-09-03 | 2013-12-20 | 24272075 FS-43d | 17d | 0d | 8/5 M-F w/JLAB Holidays ReBaseline | PROCUREMENT<$50K 60 NO ESCALATION; PROCUREMENT>$50K 69 NO ESCALATION | 99,543 | ELOUADRHIRI L | 1 | 1 | LATIFA E | 4211 |  |  |  | 13-004 |  |  |  | 24272075a | y | D | OB | 13-015 | PR | OB |  |
| 24272075b |  | Vend Fab Solenoid - Final Design Review Incetive Fee |  | 77d | 2013-09-03 | 2013-12-20 | 24272075a FS-77d | 17d | 0d | 8/5 M-F w/JLAB Holidays ReBaseline | PROCUREMENT<$50K 60 NO ESCALATION; PROCUREMENT>$50K 69 NO ESCALATION | 200,000 | ELOUADRHIRI L | 1 | 1 | LATIFA E | 4211 |  |  |  | 13-004 |  |  |  | 24272075b | y | D | OB | 13-015 | PR | OB |  |
| 24272075c |  | Vend Fab Solenoid - Peg Point #4 - Winding and Potting Tooling |  | 118d | 2013-09-03 | 2014-02-28 | 24272075b FS-77d, 24272075ba FS-77d | 17d | 0d | 8/5 M-F w/JLAB Holidays ReBaseline | PROCUREMENT>$50K 69 NO ESCALATION | 79,634 | ELOUADRHIRI L | 1 | 1 | LATIFA E | 4211 |  |  |  | 13-004 |  |  |  | 24272075c | y | D | OB | 13-015 | PR | OB |  |
| 24272075d |  | Vend Fab Solenoid - Peg Point #5 - PSMM Fabrication and Testing |  | 203d | 2013-09-03 | 2014-06-30 | 24272075c FS-118d | 17d | 0d | 8/5 M-F w/JLAB Holidays ReBaseline | PROCUREMENT>$50K 69 NO ESCALATION | 119,452 | ELOUADRHIRI L | 1 | 1 | LATIFA E | 4211 |  |  |  | 13-004 |  |  |  | 24272075d | y | D | OB | 13-015 | PR | OB |  |
| 24272075f |  | Vend Fab Solenoid - MRR Incentive Fee |  | 225d | 2013-09-03 | 2014-07-31 | 24272075d FS-203d | 17d | 0d | 8/5 M-F w/JLAB Holidays ReBaseline | PROCUREMENT>$50K 69 NO ESCALATION | 200,000 | ELOUADRHIRI L | 1 | 1 | LATIFA E | 4211 |  |  |  | 13-004 |  |  |  | 24272075f | y | D | OB | 13-015 | PR | OB |  |
| 24272075g |  | Vend Fab Solenoid - Peg Point #6 - Coils Wound |  | 246d | 2013-09-03 | 2014-08-29 | 24273010R FS-139d, 24273010K FS-139d, 24273010Q FS-250d, 24272075f FS-225d, 24273010P FS-125d | 17d | 0d | 8/5 M-F w/JLAB Holidays ReBaseline | PROCUREMENT>$50K 69 NO ESCALATION | 199,085 | ELOUADRHIRI L | 1 | 1 | LATIFA E | 4211 |  |  |  | 13-004 |  |  |  | 24272075g | y | D | OB | 13-015 | PR | OB |  |
| 24272075h |  | Vend Fab Solenoid - Peg Point #7 - Cryostat Materials and Components |  | 267d | 2013-09-03 | 2014-09-30 | 24272075g FS-246d | 17d | 0d | 8/5 M-F w/JLAB Holidays ReBaseline | PROCUREMENT>$50K 69 NO ESCALATION | 298,628 | ELOUADRHIRI L | 1 | 1 | LATIFA E | 4211 |  |  |  | 13-004 |  |  |  | 24272075h | y | D | OB | 13-015 | PR | OB |  |
| 24272075j |  | Vend Fab Solenoid - Peg Point #8 - Cold Mass Materials and Components |  | 290d | 2013-09-03 | 2014-10-31 | 24272075h FS-267d | 17d | 0d | 8/5 M-F w/JLAB Holidays ReBaseline | PROCUREMENT>$50K 69 NO ESCALATION | 298,628 | ELOUADRHIRI L | 1 | 1 | LATIFA E | 4211 |  |  |  | 13-004 |  |  |  | 24272075j | y | D | OB | 13-015 | PR | OB |  |
| 24272075k |  | Vend Fab Solenoid - Peg Point #9 - Assembly and Test |  | 308d | 2013-09-03 | 2014-11-26 | 24272075j FS-290d | 17d | 0d | 8/5 M-F w/JLAB Holidays ReBaseline | PROCUREMENT>$50K 69 NO ESCALATION | 199,085 | ELOUADRHIRI L | 1 | 1 | LATIFA E | 4211 |  |  |  | 13-004 |  |  |  | 24272075k | y | D | OB | 13-015 | PR | OB |  |
| 24272075n |  | Vend Fab Solenoid - Delivery Incentive Fee |  | 308d | 2013-09-03 | 2014-11-26 | 24272075k FS-308d | 17d | 0d | 8/5 M-F w/JLAB Holidays ReBaseline | PROCUREMENT>$50K 69 NO ESCALATION | 600,000 | ELOUADRHIRI L | 1 | 1 | LATIFA E | 4211 |  |  |  | 13-004 |  |  |  | 24272075n | y | D | OB | 13-015 | PR | OB |  |
| 24272075p |  | Vend Fab Solenoid - Peg Point #10 - Commissioning and Acceptance Test |  | 449d | 2013-09-03 | 2015-06-30 | 24272075n FS-308d | 58d | 0d | 8/5 M-F w/JLAB Holidays ReBaseline | PROCUREMENT>$50K 69 NO ESCALATION | 199,085 | ELOUADRHIRI L | 1 | 1 | LATIFA E | 4211 |  |  |  | 13-004 |  |  |  | 24272075p | y | D | OB | 13-015 | PR | OB |  |
| 24272075q |  | Vend Fab Solenoid - Peg Point #11 - Final Report and Closeout |  | 513d | 2013-09-03 | 2015-09-30 | 24272075p FS-449d | 58d | 0d | 8/5 M-F w/JLAB Holidays ReBaseline | PROCUREMENT>$50K 69 NO ESCALATION | 199,085 | ELOUADRHIRI L | 1 | 1 | LATIFA E | 4211 |  |  |  | 13-004 |  |  |  | 24272075q | y | D | OB | 13-015 | PR | OB |  |
| 24272075r |  | Vend Fab Solenoid - Peg Point #12 - Shipping Costs |  | 513d | 2013-09-03 | 2015-09-30 | 24272075q FS-513d | 58d | 55d | 8/5 M-F w/JLAB Holidays ReBaseline | PROCUREMENT>$50K 69 NO ESCALATION | 6,000 | ELOUADRHIRI L | 1 | 1 | LATIFA E | 4211 |  |  |  | 13-004 |  |  |  | 24272075r | y | D | OB | 13-015 | PR | OB |  |
| 24272080 |  | Solenoid Outside Consulting FY13 |  | 98d | 2013-09-03 | 2014-01-31 | 9-130M FS+228d | 606d | 0d | 8/5 M-F w/JLAB Holidays ReBaseline | PROCUREMENT<$50K 60 NO ESCALATION FY14; PROCUREMENT>$50K 69 NO ESCALATION FY14 | 178,380 | ELOUADRHIRI L | 1 | 1 | LATIFA E | 4211 |  |  |  | 13-004 |  |  |  | 24272080 | y | D | OB | 13-015 | PR | OB |  |
| 24272405 |  | Solenoid - Cable Testing |  | 118d | 2013-09-03 | 2014-02-28 | 9-130M FS+228d | 453d | 450d | 8/5 M-F w/JLAB Holidays ReBaseline | PROCUREMENT<$50K 60 NO ESCALATION FY14 | 24,000 | ELOUADRHIRI L | 1 | 1 | LATIFA E | 4211 |  |  |  | 13-004 |  |  |  | 24272405 | y | D | OB | 13-015 | PR | OB |  |
| 24272410 |  | Consultant Fees WS |  | 267d | 2013-09-03 | 2014-09-30 | 9-130M FS+228d | 304d | 301d | 8/5 M-F w/JLAB Holidays ReBaseline | PROCUREMENT<$50K 60 NO ESCALATION FY14 | 8,050 | ELOUADRHIRI L | 1 | 1 | LATIFA E | 4211 |  |  |  | 13-004 |  |  |  | 24272405 | y | D | OB | 13-015 | PR | OB |  |
| 24272075ba |  | De-Obligation of Vend Fab Solenoid - Final Design Review Incetive Fee |  | 1d | 2013-12-20 | 2013-12-20 | 24272075a FS-1d | 17d | 0d | 8/5 M-F w/JLAB Holidays ReBaseline | PROCUREMENT>$50K 69 NO ESCALATION | -135,000 | ELOUADRHIRI L | 1 | 1 | LATIFA E | 4211 |  |  |  | 13-004 |  |  |  | 24272075b |  | D | OB | 13-015 | PR |  |  |
| 24272085 |  | Solenoid Outside Consulting FY14 |  | 305d | 2014-02-03 | 2015-04-23 | 24272080 | 606d | 665d | 8/5 M-F w/JLAB Holidays ReBaseline | PROCUREMENT<$50K 60 NO ESCALATION FY15; PROCUREMENT>$50K 69 NO ESCALATION FY15 | 185,742 | ELOUADRHIRI L | 1 | 1 | LATIFA E | 4211 |  |  |  | 13-004 |  |  |  | 24272085 |  | D | EJ | 13-015 | PR |  | 14-001 |

| ID | WBS | Activity | Duration | Start | Finish | Predecessors | Total float | Free float | Calendar | Resources | Cost | RESP - Responsibility | STRT%COMP for CM EVM | FNSH%COMP for CM EVM | CAM RESPONSIBLE | CR 12-011 | CR 12-024 | CR 13-002 | CR 12-046 | CR 13-005 | CR 12-054 | CR 13-014 | ReBaseline Actuals Adjustment | Original Activity ID Rebaseline | EVMS Reporting Codes | BOE Procurement | CR 13-015 | Post Rebaseline | Over Under Fixed | Obligated Prior to Rebaseline | Activities with Steps | BOE Labor | BOE Expenses | CR 14-001 |
| --- | --- | --- | --- | --- | --- | --- | --- | --- | --- | --- | --- | --- | --- | --- | --- | --- | --- | --- | --- | --- | --- | --- | --- | --- | --- | --- | --- | --- | --- | --- | --- | --- | --- | --- |
|  | 3 | **1.4.2.7.3 MAGNET INFRASTRUCTURE** |  | 2011-12-01 | 2014-03-31 |  |  |  |  |  |  |  |  |  |  |  |  |  |  |  |  |  |  |  |  |  |  |  |  |  |  |  |  |  |
| 14273000 |  | Set up Solder Production line Labor Original | 37d | 2011-12-01 | 2012-01-31 | 9-120M FS+41d | 22d | 0d |  | MECH ENG [308.58 h]; MECH TECH [973.78 h] | 64,912.41 | ELOUADRHIRI L | 1 | 1 | LATIFA E | 12-011 | 12-024 | 13-002F |  |  |  |  |  |  |  |  |  |  |  |  |  |  |  |  |
| 14273005 |  | Set up Solder Production line Procurements | 57d | 2011-12-01 | 2012-02-29 | 9-120M FS+41d | 645d |  |  | PROCUREMENT<$50K 60; PROCUREMENT>$50K 69 | 150,000 | ELOUADRHIRI L | 1 | 1 | LATIFA E | 12-011 | 12-024F | 13-002F |  |  |  |  |  |  |  |  |  |  |  |  |  |  |  |  |
| 14273003 |  | Set up Solder Production line Labor Revised | 105d | 2012-02-01 | 2012-06-29 | 14273000 | 22d | 0d |  | MECH ENG [166.8 h]; MECH TECH [526.37 h] | 35,087.9 | ELOUADRHIRI L | 1 | 1 | LATIFA E |  | 12-024 | 13-002F |  |  |  |  |  |  |  |  |  |  |  |  |  |  |  |  |
| 14273010 |  | Vend Fab Wave Solder of Torus and Solenoid Magnets Peg Point #1A-Soldering Setup Part A | 22d | 2012-07-02 | 2012-07-31 | 9-120M FS+163d, 14273003 | 22d | 0d |  | PROCUREMENT<$50K 60 NO ESCALATION; PROCUREMENT>$50K 69 NO ESCALATION | 61,384 | ELOUADRHIRI L | 1 | 1 | LATIFA E |  | 12-024 | 13-002F | 12-046 |  |  |  |  |  |  |  |  |  |  |  |  |  |  |  |
| 14273014 |  | Design/Build/Install guides and rollers for inlet/outlet of process | 42d | 2012-08-01 | 2012-09-28 | 9-120M FS+205d | 21d | 0d |  | ELEC TECH [40 h]; ELEC ENG [20 h]; SUPPLIES & MATERIALS | 3,676.4 | ELOUADRHIRI L | 1 | 1 | LATIFA E |  | 12-024 | 13-002F | 12-046 |  |  |  |  |  |  |  |  |  |  |  |  |  |  |  |
| 14273010A |  | Vend Fab Wave Solder of Torus and Solenoid Magnets Peg Point #1-Soldering Setup Part B | 30d | 2012-08-17 | 2012-09-28 | 14273008 FS-125d, 14273010 FS+12d, 14273007 FS-70d | 22d | 0d |  | PROCUREMENT>$50K 69 NO ESCALATION | 38,616 | ELOUADRHIRI L | 1 | 1 | LATIFA E |  | 12-024 | 13-002F | 12-046 |  |  |  |  |  |  |  |  |  |  |  |  |  |  |  |
| 14273010B |  | Vend Fab Wave Solder of Torus and Solenoid Magnets Peg Point #2-Procurement of Materials and Start of Production | 53d | 2012-08-17 | 2012-10-31 | 14273010A FS-30d | 22d | 0d |  | PROCUREMENT>$50K 69 NO ESCALATION | 125,000 | ELOUADRHIRI L | 1 | 1 | LATIFA E |  | 12-024 | 13-002F | 12-046 |  |  |  |  |  |  |  |  |  |  |  |  |  |  |  |
| 14273010C |  | Vend Fab Wave Solder of Torus and Solenoid Magnets Peg Point #3-Delivery of Torus Conductor 001 | 73d | 2012-08-17 | 2012-11-30 | 14273010B FS-53d | 22d | 0d |  | PROCUREMENT>$50K 69 NO ESCALATION | 21,060 | ELOUADRHIRI L | 1 | 1 | LATIFA E |  | 12-024 | 13-002F | 12-046 |  |  |  |  |  |  |  |  |  |  |  |  |  |  |  |
| 14273010D |  | Vend Fab Wave Solder of Torus and Solenoid Magnets Peg Point #4-Delivery of Torus Conductor 002-006 | 110d | 2012-08-17 | 2013-01-31 | 14273010C FS-73d | 22d | 0d |  | PROCUREMENT>$50K 69 NO ESCALATION | 125,000 | ELOUADRHIRI L | 1 | 1 | LATIFA E |  | 12-024 | 13-002F | 12-046 |  |  |  |  |  |  |  |  |  |  |  |  |  |  |  |
| 14273010G |  | Vend Fab Wave Solder of Torus and Solenoid Magnets Peg Point #5-Delivery of 1st set of Solenoid Conductor Lengths 1-9 | 150d | 2012-08-17 | 2013-03-29 | 14273010D FS-110d | 22d | 0d |  | PROCUREMENT>$50K 69 NO ESCALATION | 92,985 | ELOUADRHIRI L | 1 | 1 | LATIFA E |  | 12-024 | 13-002F | 12-046 |  |  |  |  |  |  |  |  |  |  |  |  |  |  |  |
| 14273010H |  | Vend Fab Wave Solder of Torus and Solenoid Magnets Peg Point #6-Delivery of 2nd set of Solenoid Conductor Lengths 1-9 | 150d | 2012-08-17 | 2013-03-29 | 14273010G FS-150d | 22d | 0d |  | PROCUREMENT>$50K 69 NO ESCALATION | 92,985 | ELOUADRHIRI L | 1 | 1 | LATIFA E |  | 12-024 | 13-002F | 12-046 |  |  |  |  |  |  |  |  |  |  |  |  |  |  |  |
| 14273010J |  | Vend Fab Wave Solder of Torus and Solenoid Magnets Peg Point #7-Delivery of 3rd set of Solenoid Conductor Lengths 1-9 | 172d | 2012-08-17 | 2013-04-30 | 14273010H FS-150d | 22d | 0d |  | PROCUREMENT>$50K 69 NO ESCALATION | 92,985 | ELOUADRHIRI L | 1 | 1 | LATIFA E |  | 12-024 | 13-002F | 12-046 |  |  |  |  |  |  |  |  |  |  |  |  |  |  |  |
| 14273010K |  | Vend Fab Wave Solder of Torus and Solenoid Magnets Peg Point #8-Delivery of 4th set of Solenoid Conductor Lengths 1-9 | 214d | 2012-08-17 | 2013-06-28 | 14273010J FS-172d | 22d | 2d |  | PROCUREMENT>$50K 69 NO ESCALATION | 92,985 | ELOUADRHIRI L | 1 | 1 | LATIFA E |  | 12-024 | 13-002F | 12-046 |  |  |  |  |  |  |  |  |  |  |  |  |  |  |  |
| 14273011 |  | Wave Solder of Torus and Solenoid Magnets Travel FY12 | 30d | 2012-08-17 | 2012-09-28 | 9-120M FS+217d | 22d | 0d |  | SCIENTIST [84 h]; MECH TECH [168 h]; TRAVEL | 23,197.16 | ELOUADRHIRI L | 1 | 1 | LATIFA E |  | 12-024 | 13-002F | 12-046 |  |  |  |  |  |  |  |  |  |  |  |  |  |  |  |
| 14273012 |  | Wave Solder of Torus and Solenoid Magnets Travel FY13 | 184d | 2012-10-01 | 2013-06-28 | 14273011 | 22d | 2d |  | MECH TECH [576 h]; SCIENTIST [288 h]; TRAVEL | 82,070.88 | ELOUADRHIRI L | 1 | 1 | LATIFA E |  | 12-024 | 13-002F | 12-046 |  |  |  |  |  |  |  |  |  |  |  |  |  |  |  |
| 14273014A |  | Dial in the process settings - spooling and traverse speeds, manual control | 20d | 2012-10-01 | 2012-10-26 | 14273014 | 21d | 0d |  | ELEC ENG [10 h]; SR STAFF [16 h]; ELEC TECH [20 h] | 3,504.5 | ELOUADRHIRI L | 1 | 1 | LATIFA E |  | 12-024 | 13-002F | 12-046 |  |  |  |  |  |  |  |  |  |  |  |  |  |  |  |
| 14273015 |  | Cryostat Factory Setup | 59d | 2012-10-01 | 2012-12-31 | 9-130M | 189d |  |  | MECH ENG [587.13 h]; MECH TECH [463.2 h]; MECH DES [427.33 h] | 84,969.65 | ELOUADRHIRI L | 1 | 1 | LATIFA E |  | 12-024 | 13-002F |  | 13-005 |  |  |  |  |  |  |  |  |  |  |  |  |  |  |
| 14273008 |  | Additional Cu Channel and Wagon wheel spools for Torus | 70d | 2012-10-15 | 2013-01-31 | 9-130M FS+10d | 37d | 15d |  | PROCUREMENT<$50K 60 | 54,690.7 | ELOUADRHIRI L | 1 | 1 | LATIFA E |  | 12-024 | 13-002F | 12-046 |  |  |  |  |  |  |  |  |  |  |  |  |  |  |  |
| 14273007 |  | Shipping of Coductor to AES | 20d | 2012-10-29 | 2012-11-27 | 9-130M FS+20d | 22d | 0d |  | PROCUREMENT<$50K 60 | 10,319 | ELOUADRHIRI L | 1 | 1 | LATIFA E |  | 12-024 | 13-002F | 12-046 |  | 12-054 |  |  |  |  |  |  |  |  |  |  |  |  |  |
| 14273014B |  | Unspool/Measure/Respool/Inspect | 30d | 2012-10-29 | 2012-12-11 | 14273014A | 21d | 1d |  | MECH TECH [420 h] | 19,261.2 | ELOUADRHIRI L | 1 | 1 | LATIFA E |  | 12-024 | 13-002F | 12-046 |  |  |  |  |  |  |  |  |  |  |  |  |  |  |  |
| 14273020 |  | Re-Baseline Actuals Adjustment | 1d | 2013-08-30 | 2013-08-30 | 9-130M FS+227d | 20d |  |  | PROCUREMENT>$50K 69 NO ESCALATION | 33,232.83 | ELOUADRHIRI L | 1 | 1 | LATIFA E |  |  |  |  |  |  | 13-014 | ADJ |  |  |  |  |  |  |  |  |  |  |  |
| 24273007 |  | Shipping of Coductor to AES | 43d | 2013-09-03 | 2013-10-31 | 9-130M FS+228d | 528d | 525d | 8/5 M-F w/JLAB Holidays ReBaseline | PROCUREMENT<$50K 60 NO ESCALATION FY14 | 8,874.34 | ELOUADRHIRI L | 1 | 1 | LATIFA E |  | 12-024 | 13-002F | 12-046 |  | 12-054 |  |  | 24273007 | D | EJ | 13-015 | PR |  |  |  |  |  |  |
| 24273010B |  | Vend Fab Wave Solder of Torus and Solenoid Magnets Peg Point #2-Procurement of Materials and | 43d | 2013-09-03 | 2013-10-31 | 9-130M FS+228d | 17d | 0d | 8/5 M-F w/JLAB Holidays ReBaseline | PROCUREMENT<$50K 60 NO ESCALATION | 62,126.25 | ELOUADRHIRI L | 1 | 1 | LATIFA E |  | 12-024 | 13-002F | 12-046 |  |  |  |  | 24273010B | D | OB | 13-015 | PR | y | OB |  |  |  |  |
| 24273010H |  | Vend Fab Wave Solder of Torus and Solenoid Magnets Peg Point #6-Delivery of 2nd set of Solenoid Conductor Lengths 1-9 | 98d | 2013-09-03 | 2014-01-31 | 24273010B FS-43d | 17d | 0d | 8/5 M-F w/JLAB Holidays ReBaseline | PROCUREMENT<$50K 60 NO ESCALATION; PROCUREMENT>$50K 69 NO ESCALATION | 60,933.75 | ELOUADRHIRI L | 1 | 1 | LATIFA E |  | 12-024 | 13-002F | 12-046 |  |  |  |  | 24273010H | D | OB | 13-015 | PR | y | OB |  |  |  |  |
| 24273010J |  | Vend Fab Wave Solder of Torus and Solenoid Magnets Peg Point #7-Delivery of 3rd set of Solenoid Conductor Lengths 1-9 | 118d | 2013-09-03 | 2014-02-28 | 24273010H FS-98d | 17d | 0d | 8/5 M-F w/JLAB Holidays ReBaseline | PROCUREMENT>$50K 69 NO ESCALATION | 60,933.75 | ELOUADRHIRI L | 1 | 1 | LATIFA E |  | 12-024 | 13-002F | 12-046 |  |  |  |  | 24273010J | D | OB | 13-015 | PR | y | OB |  |  |  |  |
| 24273010K |  | Vend Fab Wave Solder of Torus and Solenoid Magnets Peg Point #8-Delivery of 4th set of Solenoid Conductor Lengths 1-9 | 139d | 2013-09-03 | 2014-03-31 | 24273010J FS-118d | 17d | 0d | 8/5 M-F w/JLAB Holidays ReBaseline | PROCUREMENT>$50K 69 NO ESCALATION | 60,933.75 | ELOUADRHIRI L | 1 | 1 | LATIFA E |  | 12-024 | 13-002F | 12-046 |  |  |  |  | 24273010K | D | OB | 13-015 | PR | y | OB |  |  |  |  |
| 24273010N |  | Vend Fab Wave Solder of Torus and Solenoid Magnets Peg Point #9-Additional length and splicing required for Solenoid | 129d | 2013-09-03 | 2014-03-17 | 24273010K FS-139d | 17d | 0d | 8/5 M-F w/JLAB Holidays ReBaseline | PROCUREMENT<$50K 60 NO ESCALATION FY14; PROCUREMENT>$50K 69 NO ESCALATION | 107,400 | ELOUADRHIRI L | 1 | 1 | LATIFA E |  | 12-024 | 13-002F | 12-046 |  |  |  |  | 24273010N | D | VQ | 13-015 | PR | y | OB |  |  |  |  |
| 24273010P |  | Vend Fab Wave Solder of Torus and Solenoid Magnets Peg Point #10-Additional Reels for Solenoid | 62d | 2013-09-03 | 2013-11-27 | 24273010N FS-129d | 17d | 0d | 8/5 M-F w/JLAB Holidays ReBaseline | PROCUREMENT>$50K 69 NO ESCALATION | 79,600 | ELOUADRHIRI L | 1 | 1 | LATIFA E |  | 12-024 | 13-002F | 12-046 |  |  |  |  | 24273010P | D | VQ | 13-015 | PR | y | OB |  |  |  |  |
| 24273010R |  | Vend Fab Wave Solder of Torus and Solenoid Magnets New Scope | 139d | 2013-09-03 | 2014-03-31 | 24273010P FS-62d | 17d | 0d | 8/5 M-F w/JLAB Holidays ReBaseline | PROCUREMENT>$50K 69 NO ESCALATION | 211,308.5 | ELOUADRHIRI L | 1 | 1 | LATIFA E |  | 12-024 | 13-002F | 12-046 |  |  |  |  | 24273010Q | D | VQ | 13-015 | PR | y | OB |  |  |  |  |
| 24273012 |  | Wave Solder of Torus and Solenoid Magnets Travel FY13 | 20d | 2013-09-03 | 2013-09-30 | 9-130M FS+228d | 452d | 0d | 8/5 M-F w/JLAB Holidays ReBaseline | MECH TECH [39.89 h]; SCIENTIST [19.94 h]; TRAVEL | 5,683.08 | ELOUADRHIRI L | 1 | 1 | LATIFA E |  | 12-024 | 13-002F | 12-046 |  |  |  |  | 24273012 | S |  | 13-015 | PR |  |  | ST | PE | PE |  |
| 24273017 |  | Twente Cable Testing | 77d | 2013-09-03 | 2013-12-20 | 9-130M FS+228d | 494d | 491d | 8/5 M-F w/JLAB Holidays ReBaseline | PROCUREMENT<$50K 60 NO ESCALATION FY14 | 12,271.72 | ELOUADRHIRI L | 1 | 1 | LATIFA E |  | 12-024 | 13-002F | 12-046 |  | 12-054 |  |  | 24273007 | D | EJ | 13-015 | PR | y | OB |  |  |  |  |
| 24273022 |  | Additional Cu for solenoid conductor - Procurment | 128d | 2013-09-03 | 2014-03-14 | 9-130M FS+228d | 443d | 440d | 8/5 M-F w/JLAB Holidays ReBaseline | PROCUREMENT<$50K 60 NO ESCALATION FY14 | 15,500 | ELOUADRHIRI L | 1 | 1 | LATIFA E |  | 12-024 | 13-002F | 12-046 |  |  |  |  | 24273022 | D | EJ | 13-015 | PR | y | OB |  |  |  |  |
| 24273027 |  | Consultant Fees WS | 77d | 2013-09-03 | 2013-12-20 | 9-130M FS+228d | 932d |  | 8/5 M-F w/JLAB Holidays ReBaseline | PROCUREMENT<$50K 60 NO ESCALATION FY14 | 225 | ELOUADRHIRI L | 1 | 1 | LATIFA E |  | 12-024 | 13-002F | 12-046 |  | 12-054 |  |  | 24273007 | D | EJ | 13-015 | PR | y | OB |  |  |  |  |
| 24273012a |  | Wave Solder of Torus and Solenoid Magnets Travel FY14 | 99d | 2013-10-01 | 2014-03-03 | 9-130M FS+228d, 24273012 | 452d | 449d | 8/5 M-F w/JLAB Holidays ReBaseline | MECH TECH [197.43 h]; SCIENTIST [98.72 h]; TRAVEL | 29,027.18 | ELOUADRHIRI L | 1 | 1 | LATIFA E |  | 12-024 | 13-002F | 12-046 |  |  |  |  | 24273012 | S |  | 13-015 | PR |  |  | ST | PE | PE | 14-001 |
| 24273010Q |  | Vend Fab Wave Solder of Torus and Solenoid Magnets Peg Point #10-Conductor Cleaning | 23d | 2014-02-13 | 2014-03-17 | 24273010N FS-23d | 138d | 121d | 8/5 M-F w/JLAB Holidays ReBaseline | PROCUREMENT>$50K 69 NO ESCALATION | 51,000 | ELOUADRHIRI L | 1 | 1 | LATIFA E |  | 12-024 | 13-002F | 12-046 |  |  |  |  | 24273010Q | D | VQ | 13-015 | PR | y | OB |  |  |  |  |

Notes:
- 14273011: Explanation: 7 trips - / 0.6w/trip MT / 0.3w/trip scientist / $1,400.00/trip expenses / Steps: Trip 1; Trip 2; Trip 3; Trip 4; Trip 5; Trip 6; Trip 7
- 14273012: Explanation: 24 trips - / 0.6w/trip MT / 0.3w/trip scientist / $1,400.00/trip expenses / Steps: Trip 1; Trip 2; Trip 3; Trip 4; Trip 5; Trip 6; Trip 7; Trip 8; Trip 9; Trip 10; Trip 11; Trip 12; Trip 13; Trip 14; Trip 15; Trip 16; Trip 17; Trip 18; Trip 19; Trip 20; Trip 21; Trip 22; Trip 23; Trip 24
- 24273012: Explanation: 24 trips - / 0.6w/trip MT / 0.3w/trip scientist / $1,400.00/trip expenses / Steps: Trip 15; Trip 16; Trip 17; Trip 18; Trip 19; Trip 20; Trip 21; Trip 22; Trip 23; Trip 24
- 24273022: Explanation: 24 trips - / 0.6w/trip MT / 0.3w/trip scientist / $1,400.00/trip expenses
- 24273012a: Explanation: 24 trips - / 0.6w/trip MT / 0.3w/trip scientist / $1,400.00/trip expenses / Steps: Trip 15; Trip 16; Trip 17; Trip 18; Trip 19; Trip 20; Trip 21; Trip 22; Trip 23; Trip 24

| ID | WBS | Activity | Type | Duration | Start | Finish | Predecessors | Total float | Free float | Calendar | Resources | Cost | RESP - Responsibility | STRT%COMP for CM EVM | FNSH%COMP for CM EVM | CAM RESPONSIBLE | CR 13-014 | ReBaseline Actuals Adjustment | Original Activity ID Rebaseline | EVMS Reporting Codes | 12 GEV MAJOR PROCUREMENT CATAGORY | CR 12-024 | CR 13-002 | BOE Labor | CR 13-015 | Post Rebaseline | Activities with Steps | Over Under Fixed | BOE Procurement | Obligated Prior to Rebaseline | CR 14-001 | CR 12-042 | BOE Expenses |
| --- | --- | --- | --- | --- | --- | --- | --- | --- | --- | --- | --- | --- | --- | --- | --- | --- | --- | --- | --- | --- | --- | --- | --- | --- | --- | --- | --- | --- | --- | --- | --- | --- | --- |
|  | 4 | **1.4.2.7.4 TORUS CRYOSTAT FACTORY** |  |  | 2013-08-30 | 2015-07-14 |  |  |  |  |  |  |  |  |  |  |  |  |  |  |  |  |  |  |  |  |  |  |  |  |  |  |  |
|  | 1 | **1.4.2.7.4.1 DESIGN AND PROCEDURES** |  |  | 2013-08-30 | 2013-11-15 |  |  |  |  |  |  |  |  |  |  |  |  |  |  |  |  |  |  |  |  |  |  |  |  |  |  |  |
| 142741000 |  | Re-Baseline Actuals Adjustment |  | 1d | 2013-08-30 | 2013-08-30 | 9-130M FS+227d | 20d |  |  | PROCUREMENT>$50K 69 NO ESCALATION | 122,695.66 | ELOUADRHIRI L | 1 | 1 | LATIFA E | 13-014 | ADJ |  |  |  |  |  |  |  |  |  |  |  |  |  |  |  |
| 242741010 |  | Cryostat Factory - Design lifting Fixtures and Procurement Prep (Historical) |  | 3d | 2013-09-03 | 2013-09-05 | 9-130M FS+228d | 199d | 51d | 8/5 M-F w/JLAB Holidays ReBaseline | MECH ENG [45.7 h]; MECH DES [27.57 h] | 4,677.25 | ELOUADRHIRI L | 1 | 1 | LATIFA E |  |  | 24271745 | H | 4211 | 12-024 | 13-002F | EJ | 13-015 | PR |  |  |  |  |  |  |  |
| 242741020 |  | Cryostat Factory - Perform tests for Torus Design - labor |  | 10d | 2013-09-03 | 2013-09-16 | 9-130M FS+228d | 192d | 44d | 8/5 M-F w/JLAB Holidays ReBaseline | MECH ENG [3.9 h]; MECH TECH [3.9 h] | 461.65 | ELOUADRHIRI L | 1 | 1 | LATIFA E |  |  | 24271770 | H | 4211 | 12-024 | 13-002F | EJ | 13-015 | PR |  |  |  |  |  |  |  |
| 242741030 |  | Cryostat Factory - Write, review and sign welding Procedures |  | 10d | 2013-09-03 | 2013-09-16 | 9-130M FS+228d | 192d | 44d | 8/5 M-F w/JLAB Holidays ReBaseline | SR STAFF [1.59 h]; MECH ENG [4.78 h] | 531.39 | ELOUADRHIRI L | 1 | 1 | LATIFA E |  |  | 24271780 | H | 4211 | 12-024 | 13-002F | EJ | 13-015 | PR |  |  |  |  |  |  |  |
| 242741035 |  | Cryostat Factory - Write, review and sign Incoming material QA Procedures FY13 |  | 20d | 2013-09-03 | 2013-09-30 | 9-130M FS+228d | 170d | 0d | 8/5 M-F w/JLAB Holidays ReBaseline | SR STAFF [4.98 h]; MECH ENG [19.91 h] | 2,021.26 | ELOUADRHIRI L | 1 | 1 | LATIFA E |  |  | 24271785 | S | 4211 | 12-024 | 13-002F | EJ | 13-015 | PR | ST |  |  |  |  |  |  |
| 242741040 |  | Cryostat Factory - Write, review and sign material handling Procedures FY13 |  | 20d | 2013-09-03 | 2013-09-30 | 9-130M FS+228d | 170d | 0d | 8/5 M-F w/JLAB Holidays ReBaseline | MECH ENG [1.99 h]; SR STAFF [0.99 h] | 259.58 | ELOUADRHIRI L | 1 | 1 | LATIFA E |  |  | 24271790 | H | 4211 | 12-024 | 13-002F | EJ | 13-015 | PR |  |  |  |  |  |  |  |
| 242741045 |  | Cryostat Factory - Write, review and sign MLI application Procedures |  | 10d | 2013-09-03 | 2013-09-16 | 9-130M FS+228d | 192d | 44d | 8/5 M-F w/JLAB Holidays ReBaseline | MECH ENG [3.18 h]; SR STAFF [1.59 h] | 415.49 | ELOUADRHIRI L | 1 | 1 | LATIFA E |  |  | 24271795 | H | 4211 | 12-024 | 13-002F | EJ | 13-015 | PR |  |  |  |  |  |  |  |
| 242741050 |  | Cryostat Factory - Write, review and sign OSP FY13 |  | 20d | 2013-09-03 | 2013-09-30 | 9-130M FS+228d | 148d | 0d | 8/5 M-F w/JLAB Holidays ReBaseline | MECH ENG [5.31 h]; SR STAFF [1.77 h] | 590.61 | ELOUADRHIRI L | 1 | 1 | LATIFA E |  |  | 24271800 | S | 4211 | 12-024 | 13-002F | EJ | 13-015 | PR | ST |  |  |  |  |  |  |
| 242741055 |  | Cryostat Factory - Write, review and sign assembly procedures FY13 |  | 20d | 2013-09-03 | 2013-09-30 | 9-130M FS+228d | 170d | 0d | 8/5 M-F w/JLAB Holidays ReBaseline | MECH ENG [7.47 h]; SR STAFF [1.49 h] | 714.41 | ELOUADRHIRI L | 1 | 1 | LATIFA E |  |  | 24271805 | S | 4211 | 12-024 | 13-002F | EJ | 13-015 | PR | ST |  |  |  |  |  |  |
| 242741065 |  | Cryostat Factory - Orderfixtures, tables, tools, etc. for assembly Procurement |  | 32d | 2013-09-03 | 2013-10-16 | 9-130M FS+228d | 166d | 10d | 8/5 M-F w/JLAB Holidays ReBaseline | PROCUREMENT<$50K 60 NO ESCALATION FY14 | 37,877 | ELOUADRHIRI L | 1 | 1 | LATIFA E |  |  | 24271815 | D | 4211 | 12-024 | 13-002F |  | 13-015 | PR |  | y | EV | OB |  |  |  |
| 242741070 |  | Cryostat Stand and Axle |  | 42d | 2013-09-03 | 2013-10-30 | 9-130M FS+228d | 156d | 0d | 8/5 M-F w/JLAB Holidays ReBaseline | PROCUREMENT<$50K 60 NO ESCALATION FY14 | 5,814.28 | ELOUADRHIRI L | 1 | 1 | LATIFA E |  |  | 24271815 | D | 4211 | 12-024 | 13-002F |  | 13-015 | PR |  | y | EV | OB |  |  |  |
| 242741035a |  | Cryostat Factory - Write, review and sign Incoming material QA Procedures FY14 |  | 12d | 2013-10-01 | 2013-10-16 | 242741035, 9-130M FS+228d | 170d | 22d | 8/5 M-F w/JLAB Holidays ReBaseline | SR STAFF [2.99 h]; MECH ENG [11.94 h] | 1,251.14 | ELOUADRHIRI L | 1 | 1 | LATIFA E |  |  | 24271785 | S | 4211 | 12-024 | 13-002F | EJ | 13-015 | PR | ST |  |  |  | 14-001 |  |  |
| 242741040a |  | Cryostat Factory - Write, review and sign material handling Procedures FY14 |  | 12d | 2013-10-01 | 2013-10-16 | 242741040, 9-130M FS+228d | 170d | 22d | 8/5 M-F w/JLAB Holidays ReBaseline | MECH ENG [1.19 h]; SR STAFF [0.6 h] | 160.9 | ELOUADRHIRI L | 1 | 1 | LATIFA E |  |  | 24271790 | H | 4211 | 12-024 | 13-002F | EJ | 13-015 | PR |  |  |  |  | 14-001 |  |  |
| 242741050a |  | Cryostat Factory - Write, review and sign OSP FY14 |  | 34d | 2013-10-01 | 2013-11-15 | 242741050, 9-130M FS+228d | 148d | 0d | 8/5 M-F w/JLAB Holidays ReBaseline | MECH ENG [9.02 h]; SR STAFF [3.01 h] | 1,035.57 | ELOUADRHIRI L | 1 | 1 | LATIFA E |  |  | 24271800 | S | 4211 | 12-024 | 13-002F | EJ | 13-015 | PR | ST |  |  |  | 14-001 |  |  |
| 242741055a |  | Cryostat Factory - Write, review and sign assembly procedures FY14 |  | 12d | 2013-10-01 | 2013-10-16 | 242741055, 9-130M FS+228d | 170d | 22d | 8/5 M-F w/JLAB Holidays ReBaseline | MECH ENG [4.47 h]; SR STAFF [0.9 h] | 441.84 | ELOUADRHIRI L | 1 | 1 | LATIFA E |  |  | 24271805 | S | 4211 | 12-024 | 13-002F | EJ | 13-015 | PR | ST |  |  |  | 14-001 |  |  |
| 242741070M |  | Cryostat factory fixtures and tooling in-house | milestone | 0d | 2013-10-30 | 2013-10-30 | 242741070, 242741065 | 156d | 0d | 8/5 M-F w/JLAB Holidays ReBaseline |  |  | ELOUADRHIRI L | 1 | 1 | LATIFA E |  |  | 24271820M | M | 4211 |  | 13-002F |  | 13-015 | PR |  |  |  |  |  | 12-042 |  |
| 242741075M |  | Torus Cryostat Factory Procedures In-place | milestone | 0d | 2013-11-15 | 2013-11-15 | 242741010, 242741030, 242741050, 242741035, 242741040, 242741035a, 242741055, 242741055a, 242741045, 242741020, 242741050a, 242741040a | 148d | 103d | 8/5 M-F w/JLAB Holidays ReBaseline |  |  | ELOUADRHIRI L | 1 | 1 | LATIFA E |  |  | 24271830M | M | 4211 |  | 13-002F |  | 13-015 | PR |  |  |  |  |  | 12-042 |  |
|  | 2 | **1.4.2.7.4.2 PROTOTYPE** |  |  | 2013-09-03 | 2014-07-08 |  |  |  |  |  |  |  |  |  |  |  |  |  |  |  |  |  |  |  |  |  |  |  |  |  |  |  |
| 242742000 |  | Cryostat Factory - Test Lifting Fixtures and Procedures with Wang Coil Case FY13 |  | 20d | 2013-09-03 | 2013-09-30 | 9-130M FS+228d | 132d | 0d | 8/5 M-F w/JLAB Holidays ReBaseline | MECH TECH [43.75 h]; MECH ENG [196.88 h]; SUPPLIES & MATERIALS | 18,440.09 | ELOUADRHIRI L | 1 | 1 | LATIFA E |  |  | 24271835 | S | 4211 | 12-024 | 13-002F | EJ | 13-015 | PR | ST |  |  |  |  |  | EJ |
| 242742020 |  | Cryostat Factory - Engineering oversight (Legg) FY13 |  | 20d | 2013-09-03 | 2013-09-30 | 9-130M FS+228d | 452d | 0d | 8/5 M-F w/JLAB Holidays ReBaseline | SR STAFF [168.07 h] | 19,596.96 | ELOUADRHIRI L | 1 | 1 | LATIFA E |  |  | 24271850M | E | 4211 |  | 13-002F |  | 13-015 | PR |  |  |  |  |  | 12-042 |  |
| 242742030 |  | Cryostat Factory - Pre-assembly of CCM using Wang Coil case FY13 |  | 20d | 2013-09-03 | 2013-09-30 | 9-130M FS+228d | 528.5d | 0d | 8/5 M-F w/JLAB Holidays ReBaseline | MECH TECH [192 h]; MECH ENG [64 h] | 13,436.16 | ELOUADRHIRI L | 1 | 1 | LATIFA E |  |  | 24271850M | S | 4211 |  | 13-002F |  | 13-015 | PR | ST |  |  |  |  | 12-042 |  |
| 242742015 |  | Cryostat Factory - Test Lifting Fixtures and Procedures with Wang Coil Case FY14 |  | 12d | 2013-10-01 | 2013-10-16 | 242742000, 9-130M FS+228d | 132d | 0d | 8/5 M-F w/JLAB Holidays ReBaseline | MECH TECH [26.25 h]; MECH ENG [118.13 h]; SUPPLIES & MATERIALS | 11,417.26 | ELOUADRHIRI L | 1 | 1 | LATIFA E |  |  | 24271835 | S | 4211 | 12-024 | 13-002F | EJ | 13-015 | PR | ST |  |  |  | 14-001 |  | EJ |
| 242742020a |  | Cryostat Factory - Engineering oversight (Legg) FY14 |  | 99d | 2013-10-01 | 2014-03-03 | 242742020, 9-130M FS+228d | 452d | 449d | 8/5 M-F w/JLAB Holidays ReBaseline | SR STAFF [831.93 h] | 100,097.82 | ELOUADRHIRI L | 1 | 1 | LATIFA E |  |  | 24271850M | E | 4211 |  | 13-002F |  | 13-015 | PR |  |  |  |  | 14-001 | 12-042 |  |
| 242742030a |  | Cryostat Factory - Pre-assembly of CCM using Wang Coil case FY14 |  | 22.5d | 2013-10-01 | 2013-10-31 | 242742030, 9-130M FS+228d | 528.5d | 525.5d | 8/5 M-F w/JLAB Holidays ReBaseline | MECH TECH [216 h]; MECH ENG [72 h] | 15,597.36 | ELOUADRHIRI L | 1 | 1 | LATIFA E |  |  | 24271850M | S | 4211 |  | 13-002F |  | 13-015 | PR | ST |  |  |  | 14-001 | 12-042 |  |
| 242742005 |  | Cryostat Factory - Layout Assembly area for equipment and fixtures |  | 5d | 2013-10-03 | 2013-10-09 | 242741070M FS-20d | 156d | 0d | 8/5 M-F w/JLAB Holidays ReBaseline | MECH TECH [24 h]; MECH ENG [96 h]; SR STAFF [40 h] | 13,116.8 | ELOUADRHIRI L | 1 | 1 | LATIFA E |  |  | 24271840 | S | 4211 | 12-024 | 13-002F | EJ | 13-015 | PR | ST |  |  |  | 14-001 |  |  |
| 242742010 |  | Cryostat Factory - Install equipment and fixtures in factory area |  | 24d | 2013-10-03 | 2013-11-05 | 242741070M FS-20d, 242742005 FS-5d | 156d | 111d | 8/5 M-F w/JLAB Holidays ReBaseline | MECH TECH [512 h]; MECH ENG [256 h]; SR STAFF [128 h]; SUPPLIES & MATERIALS | 61,220.88 | ELOUADRHIRI L | 1 | 1 | LATIFA E |  |  | 24271845 | S | 4211 | 12-024 | 13-002F | EJ | 13-015 | PR | ST |  |  |  | 14-001 |  | EJ |
| 242742025 |  | Cryostat Factory - Mock-up of one quarter CCM |  | 66d | 2013-10-04 | 2014-01-17 | 9-140M FS+3d | 482d | 479d | 8/5 M-F w/JLAB Holidays ReBaseline | MECH TECH [520 h]; MECH ENG [200 h] | 39,540.4 | ELOUADRHIRI L | 1 | 1 | LATIFA E |  |  | 24271850M | S | 4211 |  | 13-002F |  | 13-015 | PR | ST |  |  |  | 14-001 | 12-042 |  |
| 242742080 |  | Cryostat Factory - Rewrite procedures and lessons learned from Proto |  | 88d | 2013-10-17 | 2014-03-04 | 242742000, 242742015 | 132d | 95d | 8/5 M-F w/JLAB Holidays ReBaseline | SR STAFF [160 h]; MECH ENG [480 h] | 55,092.8 | ELOUADRHIRI L | 1 | 1 | LATIFA E |  |  | 24271865 | E | 4211 | 12-024 | 13-002F | EJ | 13-015 | PR |  |  |  |  | 14-001 |  |  |
| 242742040 |  | Cryostat Factory - Initial receipt inspection (QA) of Coil case shields |  | 77d | 2013-11-18 | 2014-03-19 | 242751115 FS-85d | 114d | 0d | 8/5 M-F w/JLAB Holidays ReBaseline | MECH TECH [60 h]; MECH ENG [60 h] | 7,319.4 | ELOUADRHIRI L | 1 | 1 | LATIFA E |  |  | 24271850M | S | 4211 |  | 13-002F |  | 13-015 | PR | ST |  |  |  | 14-001 | 12-042 |  |
| 242742045 |  | Cryostat Factory - Pre-Assemble Seven Coil case shields |  | 86d | 2013-11-18 | 2014-04-01 | 242742040 FS-77d | 114d | 69d | 8/5 M-F w/JLAB Holidays ReBaseline | MECH TECH [700 h]; MECH ENG [700 h] | 85,393 | ELOUADRHIRI L | 1 | 1 | LATIFA E |  |  | 24271850M | S | 4211 |  | 13-002F |  | 13-015 | PR | ST |  |  |  | 14-001 | 12-042 |  |
| 242742050 |  | Cryostat Factory - Initial receipt inspection (QA) of Vacuum Vessel Parts |  | 80d | 2013-12-18 | 2014-04-21 | 242751090 FS-86d | 44d | 0d | 8/5 M-F w/JLAB Holidays ReBaseline | MECH TECH [120 h] | 5,678.4 | ELOUADRHIRI L | 1 | 1 | LATIFA E |  |  | 24271850M | S | 4211 |  | 13-002F |  | 13-015 | PR | ST |  |  |  | 14-001 | 12-042 |  |
| 242742055 |  | Cryostat Factory - Pre-Assemble Seven Vacuum Jackets |  | 118d | 2013-12-18 | 2014-06-13 | 242742050 FS-80d | 44d | 0d | 8/5 M-F w/JLAB Holidays ReBaseline | MECH TECH [1080 h]; MECH ENG [220 h] | 67,533 | ELOUADRHIRI L | 1 | 1 | LATIFA E |  |  | 24271850M | S | 4211 |  | 13-002F |  | 13-015 | PR | ST |  |  |  | 14-001 | 12-042 |  |
| 242742035 |  | Cryostat Factory - Initial reciept inspection of Coil Case MLI |  | 10d | 2014-02-17 | 2014-02-28 | 242751125 FS-10d | 101d | 56d | 8/5 M-F w/JLAB Holidays ReBaseline | MECH TECH [20 h]; MECH ENG [20 h] | 2,439.8 | ELOUADRHIRI L | 1 | 1 | LATIFA E |  |  | 24271850M | S | 4211 |  | 13-002F |  | 13-015 | PR | ST |  |  |  | 14-001 | 12-042 |  |
| 242742015M |  | Cryostat Factory - Receive parts for proto cryostat | milestone | 0d | 2014-03-19 | 2014-03-19 | 242751125, 242751145, 242751090 FS-30d, 242751115 FS-30d | 106d | 62d | 8/5 M-F w/JLAB Holidays ReBaseline |  |  | ELOUADRHIRI L | 1 | 1 | LATIFA E |  |  | 24271850M | M | 4211 |  | 13-002F |  | 13-015 | PR |  |  |  |  |  | 12-042 |  |
| 242742060M |  | Cryostat Factory - Receive 1st Article (CCM #1) coil cold case | milestone | 0d | 2014-04-25 | 2014-04-25 | 242711.3035, 24271680 FS-19d | 45d | 0d | 8/5 M-F w/JLAB Holidays ReBaseline |  |  | ELOUADRHIRI L | 1 | 1 | LATIFA E |  |  | 24271855M | M | 4211 |  | 13-002F |  | 13-015 | PR |  |  |  |  |  | 12-042 |  |
| 242742065 |  | Cryostat Factory - Assemble 1st Article (CCM #1) Coil Cryostat with cold mass (Receive, QA and Pre-assembly) |  | 17d | 2014-04-25 | 2014-05-19 | 242741075M, 242742060M, 242742000, 242742010, 242742015, 242771010 | 45d | 0d | 8/5 M-F w/JLAB Holidays ReBaseline | MECH ENG [188.57 h]; SUPPLIES & MATERIALS; MECH TECH [597.14 h]; SR STAFF [94.29 h] | 57,122.24 | ELOUADRHIRI L | 1 | 1 | LATIFA E |  |  | 24271860 | S | 4211 | 12-024 | 13-002F | EJ | 13-015 | PR | ST |  |  |  | 14-001 |  | EJ |
| 242742070 |  | Cryostat Factory - Assemble 1st Article (CCM #1) Coil Cryostat with cold mass (MLI and LN2 shield assembly) |  | 17d | 2014-05-20 | 2014-06-12 | 242742065, 242742035, 242742045 FS-35d | 45d | 1d | 8/5 M-F w/JLAB Holidays ReBaseline | SUPPLIES & MATERIALS; MECH TECH [760 h]; SR STAFF [120 h]; MECH ENG [240 h] | 71,761.72 | ELOUADRHIRI L | 1 | 1 | LATIFA E |  |  | 24271862 | S | 4211 | 12-024 | 13-002F | EJ | 13-015 | PR | ST |  |  |  | 14-001 |  | EJ |
| 242742075 |  | Cryostat Factory - Assemble 1st Article (CCM #1) Coil Cryostat with cold mass (Vac jacket weld up) |  | 16d | 2014-06-16 | 2014-07-08 | 242742015M, 242742055, 242742070 | 44d | 0d | 8/5 M-F w/JLAB Holidays ReBaseline | SUPPLIES & MATERIALS; MECH TECH [651.43 h]; SR STAFF [102.86 h]; MECH ENG [205.71 h] | 62,001.38 | ELOUADRHIRI L | 1 | 1 | LATIFA E |  |  | 24271863 | S | 4211 | 12-024 | 13-002F | EJ | 13-015 | PR | ST |  |  |  | 14-001 |  | EJ |

Notes:
- 242741035: Steps: Write initial reciept inspection for LN2 shield; Write initial receipt inspection for vacuum jacket parts
- 242741050: Steps: Complete sub-OSPs for OSP; Obtain review signatures for OSP; Obtain Signatures for OSP
- 242741055: Steps: Add instrumentation installation to assembly procedure; Re-write Shield sub-assembly procedure
- 242741035a: Steps: Write initial reciept inspection for LN2 shield; Write initial receipt inspection for vacuum jacket parts
- 242741050a: Steps: Complete sub-OSPs for OSP; Obtain review signatures for OSP; Obtain Signatures for OSP
- 242741055a: Steps: Add instrumentation installation to assembly procedure; Re-write Shield sub-assembly procedure
- 242742000: Steps: Fit steel and cooling tubes into CCM; Lift with Lifting fixture
- 242742030: Steps: Install bumpers and IPS; Install Instrumentation and Quench heater; Install MLI
- 242742015: Steps: Fit steel and cooling tubes into CCM; Lift with Lifting fixture
- 242742030a: Steps: Install bumpers and IPS; Install Instrumentation and Quench heater; Install MLI
- 242742005: Steps: Physical utilities layout and facilites request complete; Assembly Tables delivered
- 242742010: Steps: Install Welding tables; Install rotation fixture; Move tooling and weld stations to factory area
- 242742025: Steps: Drawings released; Procure / fab parts; Assemble CCM sub-assembly; Assemble Shield and P tube sub-assembly
- 242742040: Steps: Verify part count to drawing; Inspect parts for dimensionality; Clean and degrease Al pieces; Inpect LN2 coupler components; Inspect LN2 Shield MLI
- 242742045: Steps: Glue and screw aluminum plates together with G10 joint; Weld P tube to plate assemblies; Weld coupler onto P tube and leak check welds; Glue Al support tubes into shield back
- 242742050: Steps: Verify part count to drawing; Inspect parts for dimensionality; Clean and degrease SS pieces
- 242742055: Steps: Assemble back, sides and stay bars and tack together; Apply welds for warage correction; Assemble front VJ plate and tack together; Clamp and weld Sides to VJ backs; remove VJ front plate and clean out tray; Straighten and seal for storage
- 242742035: Steps: Measure dimensions of piece; Examine blanket for flaws, debris, etc.
- 242742065: Steps: Initial receipt inspection (CP-Torus-CCM-INSP-COLD) of CCM; Install OOPS cups, bumpers and IPS; Install tube extensions of He cooling lines. Leak check and pressure test; Install Instrumentation and Quench heater; Install MLI
- 242742070: Steps: Assemble LN2 Shield onto CCM with Threaded Inserts and IPS; Weld P tube couplers and leak and pressure check; Glue in plugs on Al spacer tubes; Route conductors, He tubes and Instrumentation wiring through to Hex connection; Wrap MLI on LN2 shield and place MLI tubes in through holes
- 242742075: Steps: Lower CCM/LN2 shield assembly into vacuum jacket; Dress instrumentation, conductors and He lines into Hex ring connection point; Lift front vacuum jacket plate on assembly and weld in place; Lift and Weld upper vaccuum jacket in place; Straighten and weld on remaining side walls; Install OOPS supports and transport hardware. Ship to Hall B.

| ID | WBS | Activity | Type | Duration | Start | Finish | Predecessors | Total float | Free float | Calendar | Resources | Cost | RESP - Responsibility | STRT%COMP for CM EVM | FNSH%COMP for CM EVM | CAM RESPONSIBLE | CR 13-014 | ReBaseline Actuals Adjustment | Original Activity ID Rebaseline | EVMS Reporting Codes | 12 GEV MAJOR PROCUREMENT CATAGORY | CR 12-024 | CR 13-002 | BOE Labor | CR 13-015 | Post Rebaseline | CR 14-001 | Activities with Steps | BOE Expenses | CR 12-042 |
| --- | --- | --- | --- | --- | --- | --- | --- | --- | --- | --- | --- | --- | --- | --- | --- | --- | --- | --- | --- | --- | --- | --- | --- | --- | --- | --- | --- | --- | --- | --- |
|  | 3 | **1.4.2.7.4.3 PRODUCTION** |  |  | 2013-08-30 | 2015-07-14 |  |  |  |  |  |  |  |  |  |  |  |  |  |  |  |  |  |  |  |  |  |  |  |  |
| 142743000 |  | Re-Baseline Actuals Adjustment |  | 1d | 2013-08-30 | 2013-08-30 | 9-130M FS+227d | 20d |  |  | PROCUREMENT>$50K 69 NO ESCALATION | 29,404.61 | ELOUADRHIRI L | 1 | 1 | LATIFA E | 13-014 | ADJ |  |  |  |  |  |  |  |  |  |  |  |  |
| 242743125 |  | Cryostat Factory - Rework |  | 306d | 2014-02-14 | 2015-05-07 | 242742060M FS-50d | 117d | 100d | 8/5 M-F w/JLAB Holidays ReBaseline | MECH ENG [320 h]; MECH TECH [1600 h]; SR STAFF [160 h] | 118,857.6 | ELOUADRHIRI L | 1 | 1 | LATIFA E |  |  | 24271995 | E | 4211 | 12-024 | 13-002F | EJ | 13-015 | PR | 14-001 |  |  |  |
| 242743005 |  | Cryostat Factory - Assemble Coil Cryostat #2 with cold mass (Receive, QA and Pre-assembly) |  | 22d | 2014-05-29 | 2014-06-27 | 242743000M FS-1d, 242742080 FS-35d | 37d | 0d | 8/5 M-F w/JLAB Holidays ReBaseline | SR STAFF [117.33 h]; MECH ENG [234.67 h]; SUPPLIES & MATERIALS; MECH TECH [528 h] | 66,944.07 | ELOUADRHIRI L | 1 | 1 | LATIFA E |  |  | 24271875 | S | 4211 | 12-024 | 13-002F | EJ | 13-015 | PR | 14-001 | ST | EJ |  |
| 242743000M |  | Cryostat Factory - Receive production coil case #2 | milestone | 0d | 2014-05-30 | 2014-05-30 | 242711.3040 | 37d | 0d | 8/5 M-F w/JLAB Holidays ReBaseline |  |  | ELOUADRHIRI L | 1 | 1 | LATIFA E |  |  | 24271870M | M | 4211 |  | 13-002F |  | 13-015 | PR |  |  |  | 12-042 |
| 242743010 |  | Cryostat Factory - Assemble Coil Cryostat #2 with cold mass (MLI and LN2 shield assembly) |  | 17d | 2014-06-30 | 2014-07-23 | 242743005 | 37d | 0d | 8/5 M-F w/JLAB Holidays ReBaseline | MECH TECH [560 h]; SR STAFF [80 h]; MECH ENG [160 h] | 48,072 | ELOUADRHIRI L | 1 | 1 | LATIFA E |  |  | 24271880 | S | 4211 | 12-024 | 13-002F | EJ | 13-015 | PR | 14-001 | ST |  |  |
| 242743020M |  | Cryostat Factory - Receive production coil case #3 | milestone | 0d | 2014-07-03 | 2014-07-03 | 242711.3045 | 35d | 0d | 8/5 M-F w/JLAB Holidays ReBaseline |  |  | ELOUADRHIRI L | 1 | 1 | LATIFA E |  |  | 24271890M | M | 4211 |  | 13-002F |  | 13-015 | PR |  |  |  | 12-042 |
| 242743025 |  | Cryostat Factory - Assemble Coil Cryostat #3 with cold mass (Receive, QA and Pre-assembly) |  | 17d | 2014-07-03 | 2014-07-28 | 242743005, 242743020M | 35d | 0d | 8/5 M-F w/JLAB Holidays ReBaseline | SUPPLIES & MATERIALS; MECH TECH [704 h]; SR STAFF [58.67 h]; MECH ENG [117.33 h] | 59,452.33 | ELOUADRHIRI L | 1 | 1 | LATIFA E |  |  | 24271895 | S | 4211 | 12-024 | 13-002F | EJ | 13-015 | PR | 14-001 | ST | EJ |  |
| 242743015 |  | Cryostat Factory - Assemble Coil Cryostat #2 with cold mass (Vac jacket weld up) |  | 18d | 2014-07-24 | 2014-08-18 | 242743010, 242751375 FS-35d | 37d | 2d | 8/5 M-F w/JLAB Holidays ReBaseline | MECH TECH [300 h]; SR STAFF [33.33 h]; MECH ENG [66.67 h] | 23,184.67 | ELOUADRHIRI L | 1 | 1 | LATIFA E |  |  | 24271885 | S | 4211 | 12-024 | 13-002F | EJ | 13-015 | PR | 14-001 | ST |  |  |
| 242743030 |  | Cryostat Factory - Assemble Coil Cryostat #3 with cold mass (MLI and LN2 shield assembly) |  | 17d | 2014-07-29 | 2014-08-20 | 242743010, 242743025 | 35d | 0d | 8/5 M-F w/JLAB Holidays ReBaseline | MECH TECH [680 h]; SR STAFF [40 h]; MECH ENG [80 h] | 42,964 | ELOUADRHIRI L | 1 | 1 | LATIFA E |  |  | 24271900 | S | 4211 | 12-024 | 13-002F | EJ | 13-015 | PR | 14-001 | ST |  |  |
| 242743040M |  | Cryostat Factory - Receive production coil case #4 | milestone | 0d | 2014-08-11 | 2014-08-11 | 242711.3050 | 30d | 0d | 8/5 M-F w/JLAB Holidays ReBaseline |  |  | ELOUADRHIRI L | 1 | 1 | LATIFA E |  |  | 24271910M | M | 4211 |  | 13-002F |  | 13-015 | PR |  |  |  | 12-042 |
| 242743045 |  | Cryostat Factory - Assemble Coil Cryostat #4 with cold mass (Receive, QA and Pre-assembly) |  | 15d | 2014-08-11 | 2014-08-29 | 242743040M, 242743025 | 30d | 0d | 8/5 M-F w/JLAB Holidays ReBaseline | SUPPLIES & MATERIALS; MECH TECH [704 h]; SR STAFF [58.67 h]; MECH ENG [117.33 h] | 59,452.33 | ELOUADRHIRI L | 1 | 1 | LATIFA E |  |  | 24271915 | S | 4211 | 12-024 | 13-002F | EJ | 13-015 | PR | 14-001 | ST | EJ |  |
| 242743035 |  | Cryostat Factory - Assemble Coil Cryostat #3 with cold mass (Vac jacket weld up) |  | 17d | 2014-08-21 | 2014-09-15 | 242743030, 242743015 | 35d | 5d | 8/5 M-F w/JLAB Holidays ReBaseline | MECH TECH [300 h]; SR STAFF [33.33 h]; MECH ENG [66.67 h] | 23,184.67 | ELOUADRHIRI L | 1 | 1 | LATIFA E |  |  | 24271905 | S | 4211 | 12-024 | 13-002F | EJ | 13-015 | PR | 14-001 | ST |  |  |
| 242743050 |  | Cryostat Factory - Assemble Coil Cryostat #4 with cold mass (MLI and LN2 shield assembly) |  | 15d | 2014-09-02 | 2014-09-22 | 242743045, 242743030 | 30d | 0d | 8/5 M-F w/JLAB Holidays ReBaseline | MECH TECH [680 h]; SR STAFF [40 h]; MECH ENG [80 h] | 42,964 | ELOUADRHIRI L | 1 | 1 | LATIFA E |  |  | 24271920 | S | 4211 | 12-024 | 13-002F | EJ | 13-015 | PR | 14-001 | ST |  |  |
| 242743060M |  | Cryostat Factory - Receive production coil case #5 | milestone | 0d | 2014-09-16 | 2014-09-16 | 242711.3055 | 20d | 0d | 8/5 M-F w/JLAB Holidays ReBaseline |  |  | ELOUADRHIRI L | 1 | 1 | LATIFA E |  |  | 24271930M | M | 4211 |  | 13-002F |  | 13-015 | PR |  |  |  | 12-042 |
| 242743065 |  | Cryostat Factory - Assemble Coil Cryostat #5 with cold mass (Receive, QA and Pre-assembly) |  | 15d | 2014-09-16 | 2014-10-06 | 242743060M, 242743045 | 20d | 0d | 8/5 M-F w/JLAB Holidays ReBaseline | SUPPLIES & MATERIALS; MECH TECH [704 h]; SR STAFF [58.67 h]; MECH ENG [117.33 h] | 59,452.33 | ELOUADRHIRI L | 1 | 1 | LATIFA E |  |  | 24271935 | S | 4211 | 12-024 | 13-002F | EJ | 13-015 | PR | 14-001 | ST | EJ |  |
| 242743055 |  | Cryostat Factory - Assemble Coil Cryostat #4 with cold mass (Vac jacket weld up) |  | 15d | 2014-09-23 | 2014-10-13 | 242743035, 242743050 | 30d | 10d | 8/5 M-F w/JLAB Holidays ReBaseline | MECH TECH [300 h]; SR STAFF [33.33 h]; MECH ENG [66.67 h] | 23,184.67 | ELOUADRHIRI L | 1 | 1 | LATIFA E |  |  | 24271925 | S | 4211 | 12-024 | 13-002F | EJ | 13-015 | PR | 14-001 | ST |  |  |
| 242743070 |  | Cryostat Factory - Assemble Coil Cryostat #5 with cold mass (MLI and LN2 shield assembly) |  | 15d | 2014-10-07 | 2014-10-27 | 242743065, 242743050 | 20d | 0d | 8/5 M-F w/JLAB Holidays ReBaseline | MECH TECH [680 h]; SR STAFF [40 h]; MECH ENG [80 h] | 42,964 | ELOUADRHIRI L | 1 | 1 | LATIFA E |  |  | 24271940 | S | 4211 | 12-024 | 13-002F | EJ | 13-015 | PR | 14-001 | ST |  |  |
| 242743080M |  | Cryostat Factory - Receive production coil case #6 | milestone | 0d | 2014-10-15 | 2014-10-15 | 242711.3060 | 17d | 0d | 8/5 M-F w/JLAB Holidays ReBaseline |  |  | ELOUADRHIRI L | 1 | 1 | LATIFA E |  |  | 24271950M | M | 4211 |  | 13-002F |  | 13-015 | PR |  |  |  | 12-042 |
| 242743085 |  | Cryostat Factory - Assemble Coil Cryostat #6 with cold mass (Receive, QA and Pre-assembly) |  | 15d | 2014-10-15 | 2014-11-04 | 242743065, 242743080M | 17d | 0d | 8/5 M-F w/JLAB Holidays ReBaseline | SUPPLIES & MATERIALS; MECH TECH [704 h]; SR STAFF [58.67 h]; MECH ENG [117.33 h] | 59,452.33 | ELOUADRHIRI L | 1 | 1 | LATIFA E |  |  | 24271955 | S | 4211 | 12-024 | 13-002F | EJ | 13-015 | PR | 14-001 | ST | EJ |  |
| 242743075 |  | Cryostat Factory - Assemble Coil Cryostat #5 with cold mass (Vac jacket weld up) |  | 15d | 2014-10-28 | 2014-11-17 | 242743055, 242743070 | 20d | 0d | 8/5 M-F w/JLAB Holidays ReBaseline | MECH TECH [300 h]; SR STAFF [33.33 h]; MECH ENG [66.67 h] | 23,184.67 | ELOUADRHIRI L | 1 | 1 | LATIFA E |  |  | 24271945 | S | 4211 | 12-024 | 13-002F | EJ | 13-015 | PR | 14-001 | ST |  |  |
| 242743090 |  | Cryostat Factory - Assemble Coil Cryostat #6 with cold mass (MLI and LN2 shield assembly) |  | 15d | 2014-11-05 | 2014-11-25 | 242743070, 242743085 | 17d | 0d | 8/5 M-F w/JLAB Holidays ReBaseline | MECH TECH [680 h]; SR STAFF [40 h]; MECH ENG [80 h] | 42,964 | ELOUADRHIRI L | 1 | 1 | LATIFA E |  |  | 24271960 | S | 4211 | 12-024 | 13-002F | EJ | 13-015 | PR | 14-001 | ST |  |  |
| 242743095 |  | Cryostat Factory - Assemble Coil Cryostat #6 with cold mass (Vac jacket weld up) |  | 15d | 2014-11-26 | 2014-12-18 | 242743090, 242743075 | 17d | 0d | 8/5 M-F w/JLAB Holidays ReBaseline | MECH TECH [300 h]; SR STAFF [33.33 h]; MECH ENG [66.67 h] | 23,184.67 | ELOUADRHIRI L | 1 | 1 | LATIFA E |  |  | 24271965 | S | 4211 | 12-024 | 13-002F | EJ | 13-015 | PR | 14-001 | ST |  |  |
| 242743100M |  | Cryostat Factory - Receive production coil case #7 | milestone | 0d | 2015-04-10 | 2015-04-10 | 242751010, 242711.5030 | 72d | 0d | 8/5 M-F w/JLAB Holidays ReBaseline |  |  | ELOUADRHIRI L | 1 | 1 | LATIFA E |  |  | 24271970M | M | 4211 |  | 13-002F |  | 13-015 | PR |  |  |  | 12-042 |
| 242743105 |  | Cryostat Factory - Assemble Coil Cryostat #7 with cold mass (Receive, QA and Pre-assembly) |  | 15d | 2015-04-10 | 2015-04-30 | 242743100M, 242743085 | 72d | 0d | 8/5 M-F w/JLAB Holidays ReBaseline | SUPPLIES & MATERIALS; MECH TECH [704 h]; SR STAFF [58.67 h]; MECH ENG [117.33 h] | 59,452.33 | ELOUADRHIRI L | 1 | 1 | LATIFA E |  |  | 24271975 | S | 4211 | 12-024 | 13-002F | EJ | 13-015 | PR | 14-001 | ST | EJ |  |
| 242743110 |  | Cryostat Factory - Assemble Coil Cryostat #7 with cold mass (MLI and LN2 shield assembly) |  | 15d | 2015-05-01 | 2015-05-21 | 242743105, 242743090 | 72d | 0d | 8/5 M-F w/JLAB Holidays ReBaseline | SR STAFF [40 h]; MECH ENG [80 h]; MECH TECH [680 h] | 42,964 | ELOUADRHIRI L | 1 | 1 | LATIFA E |  |  | 24271980 | S | 4211 | 12-024 | 13-002F | EJ | 13-015 | PR | 14-001 | ST |  |  |
| 242743120 |  | Cryostat Factory - Clean up And ship to site |  | 40d | 2015-05-15 | 2015-07-14 | 242743115 FS-20d | 72d | 55d | 8/5 M-F w/JLAB Holidays ReBaseline | MECH ENG [240 h]; MECH TECH [360 h]; SR STAFF [120 h] | 49,394.4 | ELOUADRHIRI L | 1 | 1 | LATIFA E |  |  | 24271990 | U | 4211 | 12-024 | 13-002F | EJ | 13-015 | PR | 14-001 |  |  |  |
| 242743115 |  | Cryostat Factory - Assemble Coil Cryostat #7 with cold mass (Vac jacket weld up) |  | 15d | 2015-05-22 | 2015-06-15 | 242743095, 242743110 | 72d | 0d | 8/5 M-F w/JLAB Holidays ReBaseline | MECH TECH [300 h]; SR STAFF [33.33 h]; MECH ENG [66.67 h] | 23,184.67 | ELOUADRHIRI L | 1 | 1 | LATIFA E |  |  | 24271985 | S | 4211 | 12-024 | 13-002F | EJ | 13-015 | PR | 14-001 | ST |  |  |

Notes:
- 242743005: Steps: Initial receipt inspection (CP-Torus-CCM-INSP-COLD) of CCM; Install OOPS cups, bumpers and IPS; Install tube extensions of He cooling lines. Leak check and pressure test; Install Instrumentation and Quench heater; Install MLI
- 242743010: Steps: Assemble LN2 Shield onto CCM with Threaded Inserts and IPS; Weld P tube couplers and leak and pressure check; Glue in plugs on Al spacer tubes; Route conductors, He tubes and Instrumentation wiring through to Hex connection; Wrap MLI on LN2 shield and place MLI tubes in through holes
- 242743025: Steps: Initial receipt inspection (CP-Torus-CCM-INSP-COLD) of CCM; Install OOPS cups, bumpers and IPS; Install tube extensions of He cooling lines. Leak check and pressure test; Install Instrumentation and Quench heater; Install MLI
- 242743015: Steps: Lower CCM/LN2 shield assembly into vacuum jacket; Dress instrumentation, conductors and He lines into Hex ring connection point; Lift front vacuum jacket plate on assembly and weld in place; Lift and Weld upper vaccuum jacket in place; Straighten and weld on remaining side walls; Install OOPS supports and transport hardware. Ship to Hall B.
- 242743030: Steps: Assemble LN2 Shield onto CCM with Threaded Inserts and IPS; Weld P tube couplers and leak and pressure check; Glue in plugs on Al spacer tubes; Route conductors, He tubes and Instrumentation wiring through to Hex connection; Wrap MLI on LN2 shield and place MLI tubes in through holes
- 242743045: Steps: Initial receipt inspection (CP-Torus-CCM-INSP-COLD) of CCM; Install OOPS cups, bumpers and IPS; Install tube extensions of He cooling lines. Leak check and pressure test; Install Instrumentation and Quench heater; Install MLI
- 242743035: Steps: Lower CCM/LN2 shield assembly into vacuum jacket; Dress instrumentation, conductors and He lines into Hex ring connection point; Lift front vacuum jacket plate on assembly and weld in place; Lift and Weld upper vaccuum jacket in place; Straighten and weld on remaining side walls; Install OOPS supports and transport hardware. Ship to Hall B.
- 242743050: Steps: Assemble LN2 Shield onto CCM with Threaded Inserts and IPS; Weld P tube couplers and leak and pressure check; Glue in plugs on Al spacer tubes; Route conductors, He tubes and Instrumentation wiring through to Hex connection; Wrap MLI on LN2 shield and place MLI tubes in through holes
- 242743065: Steps: Initial receipt inspection (CP-Torus-CCM-INSP-COLD) of CCM; Install OOPS cups, bumpers and IPS; Install tube extensions of He cooling lines. Leak check and pressure test; Install Instrumentation and Quench heater; Install MLI
- 242743055: Steps: Lower CCM/LN2 shield assembly into vacuum jacket; Dress instrumentation, conductors and He lines into Hex ring connection point; Lift front vacuum jacket plate on assembly and weld in place; Lift and Weld upper vaccuum jacket in place; Straighten and weld on remaining side walls; Install OOPS supports and transport hardware. Ship to Hall B.
- 242743070: Steps: Assemble LN2 Shield onto CCM with Threaded Inserts and IPS; Weld P tube couplers and leak and pressure check; Glue in plugs on Al spacer tubes; Route conductors, He tubes and Instrumentation wiring through to Hex connection; Wrap MLI on LN2 shield and place MLI tubes in through holes
- 242743085: Steps: Initial receipt inspection (CP-Torus-CCM-INSP-COLD) of CCM; Install OOPS cups, bumpers and IPS; Install tube extensions of He cooling lines. Leak check and pressure test; Install Instrumentation and Quench heater; Install MLI
- 242743075: Steps: Lower CCM/LN2 shield assembly into vacuum jacket; Dress instrumentation, conductors and He lines into Hex ring connection point; Lift front vacuum jacket plate on assembly and weld in place; Lift and Weld upper vaccuum jacket in place; Straighten and weld on remaining side walls; Install OOPS supports and transport hardware. Ship to Hall B.
- 242743090: Steps: Assemble LN2 Shield onto CCM with Threaded Inserts and IPS; Weld P tube couplers and leak and pressure check; Glue in plugs on Al spacer tubes; Route conductors, He tubes and Instrumentation wiring through to Hex connection; Wrap MLI on LN2 shield and place MLI tubes in through holes
- 242743095: Steps: Lower CCM/LN2 shield assembly into vacuum jacket; Dress instrumentation, conductors and He lines into Hex ring connection point; Lift front vacuum jacket plate on assembly and weld in place; Lift and Weld upper vaccuum jacket in place; Straighten and weld on remaining side walls; Install OOPS supports and transport hardware. Ship to Hall B.
- 242743105: Steps: Initial receipt inspection (CP-Torus-CCM-INSP-COLD) of CCM; Install OOPS cups, bumpers and IPS; Install tube extensions of He cooling lines. Leak check and pressure test; Install Instrumentation and Quench heater; Install MLI
- 242743110: Steps: Assemble LN2 Shield onto CCM with Threaded Inserts and IPS; Weld P tube couplers and leak and pressure check; Glue in plugs on Al spacer tubes; Route conductors, He tubes and Instrumentation wiring through to Hex connection; Wrap MLI on LN2 shield and place MLI tubes in through holes
- 242743115: Steps: Lower CCM/LN2 shield assembly into vacuum jacket; Dress instrumentation, conductors and He lines into Hex ring connection point; Lift front vacuum jacket plate on assembly and weld in place; Lift and Weld upper vaccuum jacket in place; Straighten and weld on remaining side walls; Install OOPS supports and transport hardware. Ship to Hall B.

| ID | WBS | Activity | Duration | Start | Finish | Predecessors | Total float | Free float | Calendar | Resources | Cost | RESP - Responsibility | STRT%COMP for CM EVM | FNSH%COMP for CM EVM | CAM RESPONSIBLE | CR 13-014 | ReBaseline Actuals Adjustment | Original Activity ID Rebaseline | EVMS Reporting Codes | 12 GEV MAJOR PROCUREMENT CATAGORY | Phil Dev | CR 12-024 | CR 13-002 | BOE Labor | CR 13-015 | Post Rebaseline | Over Under Fixed | Obligated Prior to Rebaseline | BOE Procurement | CR 14-001 |
| --- | --- | --- | --- | --- | --- | --- | --- | --- | --- | --- | --- | --- | --- | --- | --- | --- | --- | --- | --- | --- | --- | --- | --- | --- | --- | --- | --- | --- | --- | --- |
|  | 5 | **1.4.2.7.5 TORUS MAGNET DESIGN/PARTS** |  | 2013-08-30 | 2014-10-21 |  |  |  |  |  |  |  |  |  |  |  |  |  |  |  |  |  |  |  |  |  |  |  |  |  |
|  | 1 | **1.4.2.7.5.1 TORUS MAGNET DESIGN/PARTS** |  | 2013-08-30 | 2014-10-21 |  |  |  |  |  |  |  |  |  |  |  |  |  |  |  |  |  |  |  |  |  |  |  |  |  |
| 142751000 |  | Re-Baseline Actuals Adjustment | 1d | 2013-08-30 | 2013-08-30 | 9-130M FS+227d | 20d |  |  | PROCUREMENT>$50K 69 NO ESCALATION | 157,161.06 | ELOUADRHIRI L | 1 | 1 | LATIFA E | 13-014 | ADJ |  |  |  |  |  |  |  |  |  |  |  |  |  |
| 242751000LOE |  | Torus - Engineering Oversight FY13 | 20d | 2013-09-03 | 2013-09-30 | 9-130M FS+228d | 420d | 0d | 8/5 M-F w/JLAB Holidays ReBaseline | SR STAFF [187.92 h] | 21,911.47 | ELOUADRHIRI L | 1 | 1 | LATIFA E |  |  | 24271000LOE | E | 4211 | Phil | 12-024 | 13-002F | EJ | 13-015 | PR |  |  |  |  |
| 242751010 |  | Vend Fab Additional Coil Case for Coil # 7 | 139d | 2013-09-03 | 2014-03-31 | 9-130M FS+228d | 326d | 254d | 8/5 M-F w/JLAB Holidays ReBaseline | PROCUREMENT<$50K 60 NO ESCALATION FY14 | 25,220 | ELOUADRHIRI L | 1 | 1 | LATIFA E |  |  | 24272180 | D | 4211 |  | 12-024 | 13-002F | EJ | 13-015 | PR | y | OB |  |  |
| 242751020 |  | Torus - 1st Article Coil Case Procurement | 10d | 2013-09-03 | 2013-09-16 | 9-130M FS+228d | 90d | 70d | 8/5 M-F w/JLAB Holidays ReBaseline | PROCUREMENT<$50K 60 | 20,369.71 | ELOUADRHIRI L | 1 | 1 | LATIFA E |  |  | 24271024 | D | 4211 | Phil | 12-024 | 13-002F |  | 13-015 | PR | y | OB | VQ |  |
| 242751045 |  | Torus - 6 Production Coil Cases Procurement | 139d | 2013-09-03 | 2014-03-31 | 9-130M FS+228d | 20d | 0d | 8/5 M-F w/JLAB Holidays ReBaseline | PROCUREMENT<$50K 60 NO ESCALATION FY14; PROCUREMENT>$50K 69 NO ESCALATION FY14 | 146,130.3 | ELOUADRHIRI L | 1 | 1 | LATIFA E |  |  | 24271054 | D | 4211 | Phil | 12-024 | 13-002F |  | 13-015 | PR | y | OB | VQ |  |
| 242751050 |  | Torus - 4K MLI Modeling and Drafting | 10d | 2013-09-03 | 2013-09-16 | 9-130M FS+228d | 101d | 0d | 8/5 M-F w/JLAB Holidays ReBaseline | MECH DES [20 h] | 994.2 | ELOUADRHIRI L | 1 | 1 | LATIFA E |  |  | 24271055 | H | 4211 | Phil | 12-024 | 13-002F | EJ | 13-015 | PR |  |  |  |  |
| 242751080 |  | Torus - Vacuum Vessel Instrumentation Drafting | 20d | 2013-09-03 | 2013-09-30 | 9-130M FS+228d | 44d | 0d | 8/5 M-F w/JLAB Holidays ReBaseline | MECH DES [21.6 h] | 1,073.74 | ELOUADRHIRI L | 1 | 1 | LATIFA E |  |  | 24271090 | H | 4211 | Phil | 12-024 | 13-002F | EJ | 13-015 | PR |  |  |  |  |
| 242751110 |  | Torus - Coil Case Shields Procurement Prep FY13 | 20d | 2013-09-03 | 2013-09-30 | 9-130M FS+228d | 114d | 0d | 8/5 M-F w/JLAB Holidays ReBaseline | MECH ENG [10.91 h] | 789.45 | ELOUADRHIRI L | 1 | 1 | LATIFA E |  |  | 24271112 | H | 4211 | Phil | 12-024 | 13-002F | EJ | 13-015 | PR |  |  |  |  |
| 242751155 |  | Torus - Cold Hub - Hub analysis with off design loads | 10d | 2013-09-03 | 2013-09-16 | 9-130M FS+228d | 59d | 0d | 8/5 M-F w/JLAB Holidays ReBaseline | MECH ENG [48 h] | 3,473.28 | ELOUADRHIRI L | 1 | 1 | LATIFA E |  |  | 24271135 | H | 4211 | Phil | 12-024 | 13-002F | EJ | 13-015 | PR |  |  |  |  |
| 242751160 |  | Torus - Cold Hub - Hub Shield Modeling FY13 | 20d | 2013-09-03 | 2013-09-30 | 242751155 FS-10d | 70d | 0d | 8/5 M-F w/JLAB Holidays ReBaseline | MECH ENG [7.11 h] | 514.48 | ELOUADRHIRI L | 1 | 1 | LATIFA E |  |  | 24271140 | H | 4211 | Phil | 12-024 | 13-002F | EJ | 13-015 | PR |  |  |  |  |
| 242751165 |  | Torus - Cold Hub - Hub Shield straping for cooling design FY13 | 20d | 2013-09-03 | 2013-09-30 | 242751160 FS-54d, 242751160a FS-54d | 70d | 0d | 8/5 M-F w/JLAB Holidays ReBaseline | MECH ENG [2.58 h] | 186.69 | ELOUADRHIRI L | 1 | 1 | LATIFA E |  |  | 24271145 | H | 4211 | Phil | 12-024 | 13-002F | EJ | 13-015 | PR |  |  |  |  |
| 242751185 |  | Torus - Upstream Hex - 4K Beam Stress Analysis | 9d | 2013-09-03 | 2013-09-13 | 242751155 FS-10d | 91d | 0d | 8/5 M-F w/JLAB Holidays ReBaseline | MECH ENG [40 h] | 2,894.4 | ELOUADRHIRI L | 1 | 1 | LATIFA E |  |  | 24271155 | H | 4211 | Phil | 12-024 | 13-002F | EJ | 13-015 | PR |  |  |  |  |
| 242751195 |  | Torus - Upstream Hex - Coil to Coil lead force analysis and flexibility analysis | 19d | 2013-09-03 | 2013-09-27 | 242751190a FS-35d, 242751190 FS-35d, 242751185 FS-9d | 91d | 0d | 8/5 M-F w/JLAB Holidays ReBaseline | MECH ENG [20 h] | 1,447.2 | ELOUADRHIRI L | 1 | 1 | LATIFA E |  |  | 24271165 | H | 4211 | Phil | 12-024 | 13-002F | EJ | 13-015 | PR |  |  |  |  |
| 242751200 |  | Torus - Upstream Hex - Recooler final design FY13 | 20d | 2013-09-03 | 2013-09-30 | 242751195 FS-19d | 91d | 0d | 8/5 M-F w/JLAB Holidays ReBaseline | MECH DES [25.45 h] | 1,265.12 | ELOUADRHIRI L | 1 | 1 | LATIFA E |  |  | 24271170 | S | 4211 | Phil | 12-024 | 13-002F | EJ | 13-015 | PR |  |  |  |  |
| 242751205 |  | Torus - Upstream Hex - Recooler Mounting FY13 | 20d | 2013-09-03 | 2013-09-30 | 242751200 FS-44d, 242751200a FS-44d | 91d | 0d | 8/5 M-F w/JLAB Holidays ReBaseline | MECH DES [6.55 h] | 325.6 | ELOUADRHIRI L | 1 | 1 | LATIFA E |  |  | 24271175 | H | 4211 | Phil | 12-024 | 13-002F | EJ | 13-015 | PR |  |  |  |  |
| 242751215 |  | Torus - Upstream Hex - Splice design and tooling design FY13 | 20d | 2013-09-03 | 2013-09-30 | 242751205a FS-44d, 242751205 FS-44d | 91d | 0d | 8/5 M-F w/JLAB Holidays ReBaseline | MECH DES [21.33 h] | 1,060.31 | ELOUADRHIRI L | 1 | 1 | LATIFA E |  |  | 24271180 | S | 4211 | Phil | 12-024 | 13-002F | EJ | 13-015 | PR |  |  |  |  |
| 242751220 |  | Torus - Upstream Hex - Piping flexibility analysis | 19d | 2013-09-03 | 2013-09-27 | 242751190a FS-35d, 242751190 FS-35d | 59d | 0d | 8/5 M-F w/JLAB Holidays ReBaseline | MECH ENG [28 h] | 2,026.08 | ELOUADRHIRI L | 1 | 1 | LATIFA E |  |  | 24271185 | H | 4211 | Phil | 12-024 | 13-002F | EJ | 13-015 | PR |  |  |  |  |
| 242751345 |  | Torus - Main Cold mass support system - Supports Analyses | 20d | 2013-09-03 | 2013-09-30 | 9-130M FS+228d | 25d | 0d | 8/5 M-F w/JLAB Holidays ReBaseline | MECH ENG [16 h] | 1,157.76 | ELOUADRHIRI L | 1 | 1 | LATIFA E |  |  | 24271240 | H | 4211 | Phil | 12-024 | 13-002F | EJ | 13-015 | PR |  |  |  |  |
| 242751350 |  | Torus - Main Cold mass support system - Supports Modeling FY13 | 20d | 2013-09-03 | 2013-09-30 | 242751345 FS-20d | 25d | 0d | 8/5 M-F w/JLAB Holidays ReBaseline | MECH DES [8 h] | 397.68 | ELOUADRHIRI L | 1 | 1 | LATIFA E |  |  | 24271245 | H | 4211 | Phil | 12-024 | 13-002F | EJ | 13-015 | PR |  |  |  |  |
| 242751355 |  | Torus - Main Cold mass support system - Supports Drafting FY13 | 20d | 2013-09-03 | 2013-09-30 | 242751350 FS-40d, 242751350a FS-40d | 25d | 0d | 8/5 M-F w/JLAB Holidays ReBaseline | MECH DES [16 h] | 795.36 | ELOUADRHIRI L | 1 | 1 | LATIFA E |  |  | 24271250 | H | 4211 | Phil | 12-024 | 13-002F | EJ | 13-015 | PR |  |  |  |  |
| 242751425 |  | Torus - LOV analyses - 4K piping analysis FY13 | 20d | 2013-09-03 | 2013-09-30 | 9-130M FS+228d | 521d | 0d | 8/5 M-F w/JLAB Holidays ReBaseline | MECH ENG [16.33 h] | 1,181.64 | ELOUADRHIRI L | 1 | 1 | LATIFA E |  |  | 24271268 | H | 4211 | Phil | 12-024 | 13-002F | EJ | 13-015 | PR |  |  |  |  |
| 242751445 |  | Torus - Engineering Procured Labor Phase 1 | 20d | 2013-09-03 | 2013-09-30 | 9-130M FS+228d | 410d | 0d | 8/5 M-F w/JLAB Holidays ReBaseline | PROCUREMENT<$50K 60 | 35,259.3 | ELOUADRHIRI L | 1 | 1 | LATIFA E |  |  | 24271370 | D | 4211 |  | 12-024 | 13-002F |  | 13-015 | PR |  |  | OB |  |
| 242751430 |  | Torus - LOV analyses - LN2 Piping FY13 | 15d | 2013-09-10 | 2013-09-30 | 242751425 FS-44d, 242751425a FS-44d | 521d | 0d | 8/5 M-F w/JLAB Holidays ReBaseline | MECH ENG [13.33 h] | 964.56 | ELOUADRHIRI L | 1 | 1 | LATIFA E |  |  | 24271270 | H | 4211 | Phil | 12-024 | 13-002F | EJ | 13-015 | PR |  |  |  |  |
| 242751120 |  | Torus - Coil Case MLI Procurement Prep FY13 | 10d | 2013-09-17 | 2013-09-30 | 242751050 | 101d | 0d | 8/5 M-F w/JLAB Holidays ReBaseline | MECH ENG [9.09 h] | 657.75 | ELOUADRHIRI L | 1 | 1 | LATIFA E |  |  | 24271116 | H | 4211 | Phil | 12-024 | 13-002F | EJ | 13-015 | PR |  |  |  |  |
| 242751190 |  | Torus - Upstream Hex - Piping mounting design FY13 | 10d | 2013-09-17 | 2013-09-30 | 242751155 | 59d | 0d | 8/5 M-F w/JLAB Holidays ReBaseline | MECH DES [16 h] | 795.36 | ELOUADRHIRI L | 1 | 1 | LATIFA E |  |  | 24271160 | H | 4211 | Phil | 12-024 | 13-002F | EJ | 13-015 | PR |  |  |  |  |
| 242751435 |  | Torus - LOV analyses - Service module FY13 | 10d | 2013-09-17 | 2013-09-30 | 242751430a FS-40d, 242751430 FS-40d | 521d | 0d | 8/5 M-F w/JLAB Holidays ReBaseline | MECH ENG [10 h] | 723.6 | ELOUADRHIRI L | 1 | 1 | LATIFA E |  |  | 24271275 | H | 4211 | Phil | 12-024 | 13-002F | EJ | 13-015 | PR |  |  |  |  |
| 242751005LOE |  | Torus - Engineering Oversight FY14 | 247d | 2013-10-01 | 2014-09-30 | 242751000LOE | 420d | 0d | 8/5 M-F w/JLAB Holidays ReBaseline | SR STAFF [2360 h] | 283,955.2 | ELOUADRHIRI L | 1 | 1 | LATIFA E |  |  | 24271005LOE | E | 4211 | Phil | 12-024 | 13-002F | EJ | 13-015 | PR |  |  |  | 14-001 |
| 242751110a |  | Torus - Coil Case Shields Procurement Prep FY14 | 24d | 2013-10-01 | 2013-11-01 | 9-130M FS+228d, 242751110 | 114d | 0d | 8/5 M-F w/JLAB Holidays ReBaseline | MECH ENG [13.09 h] | 977.43 | ELOUADRHIRI L | 1 | 1 | LATIFA E |  |  | 24271112 | H | 4211 | Phil | 12-024 | 13-002F | EJ | 13-015 | PR |  |  |  | 14-001 |
| 242751120a |  | Torus - Coil Case MLI Procurement Prep FY14 | 34d | 2013-10-01 | 2013-11-15 | 242751050, 242751120 | 101d | 0d | 8/5 M-F w/JLAB Holidays ReBaseline | MECH ENG [30.91 h] | 2,308.05 | ELOUADRHIRI L | 1 | 1 | LATIFA E |  |  | 24271116 | H | 4211 | Phil | 12-024 | 13-002F | EJ | 13-015 | PR |  |  |  | 14-001 |
| 242751160a |  | Torus - Cold Hub - Hub Shield Modeling FY14 | 34d | 2013-10-01 | 2013-11-15 | 242751160, 242751155 FS-10d | 70d | 0d | 8/5 M-F w/JLAB Holidays ReBaseline | MECH ENG [12.09 h] | 902.76 | ELOUADRHIRI L | 1 | 1 | LATIFA E |  |  | 24271140 | H | 4211 | Phil | 12-024 | 13-002F | EJ | 13-015 | PR |  |  |  | 14-001 |
| 242751165a |  | Torus - Cold Hub - Hub Shield straping for cooling design FY14 | 42d | 2013-10-01 | 2013-11-27 | 242751160 FS-54d, 242751165, 242751160a FS-54d | 70d | 0d | 8/5 M-F w/JLAB Holidays ReBaseline | MECH ENG [5.42 h] | 404.71 | ELOUADRHIRI L | 1 | 1 | LATIFA E |  |  | 24271145 | H | 4211 | Phil | 12-024 | 13-002F | EJ | 13-015 | PR |  |  |  | 14-001 |
| 242751190a |  | Torus - Upstream Hex - Piping mounting design FY14 | 15d | 2013-10-01 | 2013-10-21 | 242751190, 242751155 | 59d | 0d | 8/5 M-F w/JLAB Holidays ReBaseline | MECH DES [24 h] | 1,231.2 | ELOUADRHIRI L | 1 | 1 | LATIFA E |  |  | 24271160 | H | 4211 | Phil | 12-024 | 13-002F | EJ | 13-015 | PR |  |  |  | 14-001 |
| 242751200a |  | Torus - Upstream Hex - Recooler final design FY14 | 24d | 2013-10-01 | 2013-11-01 | 242751200, 242751195 FS-19d | 91d | 0d | 8/5 M-F w/JLAB Holidays ReBaseline | MECH DES [30.54 h] | 1,566.7 | ELOUADRHIRI L | 1 | 1 | LATIFA E |  |  | 24271170 | S | 4211 | Phil | 12-024 | 13-002F | EJ | 13-015 | PR |  |  |  | 14-001 |
| 242751205a |  | Torus - Upstream Hex - Recooler Mounting FY14 | 24d | 2013-10-01 | 2013-11-01 | 242751200 FS-44d, 242751205, 242751200a FS-44d | 91d | 0d | 8/5 M-F w/JLAB Holidays ReBaseline | MECH DES [7.85 h] | 402.71 | ELOUADRHIRI L | 1 | 1 | LATIFA E |  |  | 24271175 | H | 4211 | Phil | 12-024 | 13-002F | EJ | 13-015 | PR |  |  |  | 14-001 |
| 242751215a |  | Torus - Upstream Hex - Splice design and tooling design FY14 | 34d | 2013-10-01 | 2013-11-15 | 242751205a FS-44d, 242751205 FS-44d, 242751215 | 91d | 0d | 8/5 M-F w/JLAB Holidays ReBaseline | MECH DES [36.27 h] | 1,860.65 | ELOUADRHIRI L | 1 | 1 | LATIFA E |  |  | 24271180 | S | 4211 | Phil | 12-024 | 13-002F | EJ | 13-015 | PR |  |  |  | 14-001 |
| 242751350a |  | Torus - Main Cold mass support system - Supports Modeling FY14 | 20d | 2013-10-01 | 2013-10-28 | 242751345 FS-20d, 242751350 | 25d | 0d | 8/5 M-F w/JLAB Holidays ReBaseline | MECH DES [8 h] | 410.4 | ELOUADRHIRI L | 1 | 1 | LATIFA E |  |  | 24271245 | H | 4211 | Phil | 12-024 | 13-002F | EJ | 13-015 | PR |  |  |  | 14-001 |
| 242751355a |  | Torus - Main Cold mass support system - Supports Drafting FY14 | 20d | 2013-10-01 | 2013-10-28 | 242751350 FS-40d, 242751355, 242751350a FS-40d | 25d | 0d | 8/5 M-F w/JLAB Holidays ReBaseline | MECH DES [16 h] | 820.8 | ELOUADRHIRI L | 1 | 1 | LATIFA E |  |  | 24271250 | H | 4211 | Phil | 12-024 | 13-002F | EJ | 13-015 | PR |  |  |  | 14-001 |
| 242751425a |  | Torus - LOV analyses - 4K piping analysis FY14 | 29d | 2013-10-01 | 2013-11-08 | 9-130M FS+228d, 242751425 | 521d | 0d | 8/5 M-F w/JLAB Holidays ReBaseline | MECH ENG [23.67 h] | 1,767.44 | ELOUADRHIRI L | 1 | 1 | LATIFA E |  |  | 24271268 | H | 4211 | Phil | 12-024 | 13-002F | EJ | 13-015 | PR |  |  |  | 14-001 |
| 242751430a |  | Torus - LOV analyses - LN2 Piping FY14 | 30d | 2013-10-01 | 2013-11-11 | 242751430, 242751425a FS-44d, 242751425 FS-44d | 521d | 0d | 8/5 M-F w/JLAB Holidays ReBaseline | MECH ENG [26.67 h] | 1,991.45 | ELOUADRHIRI L | 1 | 1 | LATIFA E |  |  | 24271270 | H | 4211 | Phil | 12-024 | 13-002F | EJ | 13-015 | PR |  |  |  | 14-001 |
| 242751435a |  | Torus - LOV analyses - Service module FY14 | 30d | 2013-10-01 | 2013-11-11 | 242751430a FS-40d, 242751435, 242751430 FS-40d | 521d | 518d | 8/5 M-F w/JLAB Holidays ReBaseline | MECH ENG [30 h] | 2,240.1 | ELOUADRHIRI L | 1 | 1 | LATIFA E |  |  | 24271275 | H | 4211 | Phil | 12-024 | 13-002F | EJ | 13-015 | PR |  |  |  | 14-001 |
| 242751450 |  | Torus - Engineering Procured Labor Phase 2 | 141d | 2013-10-01 | 2014-04-30 | 242751445 | 410d | 407d | 8/5 M-F w/JLAB Holidays ReBaseline | PLABOR |  | ELOUADRHIRI L | 1 | 1 | LATIFA E |  |  | 24271375 | D | 4211 |  | 12-024 | 13-002F | EJ | 13-015 | PR |  |  |  |  |
| 242751090 |  | Torus - Vacuum Vessel Assembly Parts Procurement | 139d | 2013-10-02 | 2014-04-29 | 242751080 FS+1d | 44d | 0d | 8/5 M-F w/JLAB Holidays ReBaseline | PROCUREMENT<$50K 60; PROCUREMENT>$50K 69 | 257,975 | ELOUADRHIRI L | 1 | 1 | LATIFA E |  |  | 24271094 | D | 4211 | Phil | 12-024 | 13-002F |  | 13-015 | PR |  |  | EV | 14-001 |
| 242751265 |  | Torus - Downstream Hex - 4K beam Stress Analysis | 10d | 2013-10-14 | 2013-10-25 | 242751215a FS-25d, 242751215 FS-25d | 91d | 0d | 8/5 M-F w/JLAB Holidays ReBaseline | MECH ENG [80 h] | 5,973.6 | ELOUADRHIRI L | 1 | 1 | LATIFA E |  |  | 24271203 | H | 4211 | Phil | 12-024 | 13-002F | EJ | 13-015 | PR |  |  |  | 14-001 |
| 242751150 |  | Torus - Cold Hub - Magnet construction analysis | 43d | 2013-10-15 | 2013-12-16 | 9-140M FS+10d | 81d | 11d | 8/5 M-F w/JLAB Holidays ReBaseline | MECH ENG [33.6 h] | 2,508.91 | ELOUADRHIRI L | 1 | 1 | LATIFA E |  |  | 24271130 | S | 4211 | Phil | 12-024 | 13-002F | EJ | 13-015 | PR |  |  |  | 14-001 |
| 242751145 |  | Torus - Out Of Plane Supports - OOPS Procurement | 87d | 2013-10-16 | 2014-02-28 | 9-140M FS+11d | 118d | 12d | 8/5 M-F w/JLAB Holidays ReBaseline | PROCUREMENT<$50K 60; PROCUREMENT>$50K 69 | 144,466 | ELOUADRHIRI L | 1 | 1 | LATIFA E |  |  | 24271129 | D | 4211 | Phil | 12-024 | 13-002F |  | 13-015 | PR |  |  | EV | 14-001 |
| 242751115 |  | Torus - Coil Case Shields Procurement | 95d | 2013-11-04 | 2014-03-31 | 242751110, 242751110a | 114d | 0d | 8/5 M-F w/JLAB Holidays ReBaseline | PROCUREMENT<$50K 60; PROCUREMENT>$50K 69 | 149,223.06 | ELOUADRHIRI L | 1 | 1 | LATIFA E |  |  | 24271114 | D | 4211 | Phil | 12-024 | 13-002F |  | 13-015 | PR |  |  | EV | 14-001 |
| 242751210 |  | Torus - Upstream Hex - Recooler Drafting | 18d | 2013-11-04 | 2013-11-27 | 242751200, 242751205a, 242751205, 242751200a | 105d | 0d | 8/5 M-F w/JLAB Holidays ReBaseline | MECH DES [36 h] | 1,846.8 | ELOUADRHIRI L | 1 | 1 | LATIFA E |  |  | 24271177 | H | 4211 | Phil | 12-024 | 13-002F | EJ | 13-015 | PR |  |  |  | 14-001 |
| 242751225 |  | Torus - Upstream Hex - Shield final design and Drafting | 18d | 2013-11-04 | 2013-11-27 | 242751220 FS+25d | 59d | 0d | 8/5 M-F w/JLAB Holidays ReBaseline | MECH DES [108.8 h] | 5,581.44 | ELOUADRHIRI L | 1 | 1 | LATIFA E |  |  | 24271190 | S | 4211 | Phil | 12-024 | 13-002F | EJ | 13-015 | PR |  |  |  | 14-001 |
| 242751230 |  | Torus - Upstream Hex - VJ final design and Drafting | 43d | 2013-11-04 | 2014-01-15 | 242751225 FS-18d | 59d | 0d | 8/5 M-F w/JLAB Holidays ReBaseline | MECH DES [40 h]; MECH ENG [40 h] | 5,038.8 | ELOUADRHIRI L | 1 | 1 | LATIFA E |  |  | 24271195 | H | 4211 | Phil | 12-024 | 13-002F | EJ | 13-015 | PR |  |  |  | 14-001 |
| 242751275 |  | Torus - Downstream Hex - Shield final design and Drafting | 25d | 2013-11-08 | 2013-12-16 | 242751270 FS-6d | 91d | 0d | 8/5 M-F w/JLAB Holidays ReBaseline | MECH DES [136 h] | 6,976.8 | ELOUADRHIRI L | 1 | 1 | LATIFA E |  |  | 24271210 | H | 4211 | Phil | 12-024 | 13-002F | EJ | 13-015 | PR |  |  |  | 14-001 |
| 242751270 |  | Torus - Downstream Hex - 4K piping analysis | 5d | 2013-11-11 | 2013-11-15 | 242751265 FS+10d | 91d | 0d | 8/5 M-F w/JLAB Holidays ReBaseline | MECH ENG [40 h] | 2,986.8 | ELOUADRHIRI L | 1 | 1 | LATIFA E |  |  | 24271205 | H | 4211 | Phil | 12-024 | 13-002F | EJ | 13-015 | PR |  |  |  | 14-001 |
| 242751125 |  | Torus - Coil Case MLI Procurement | 64d | 2013-11-18 | 2014-02-28 | 242751120, 242751120a | 101d | 0d | 8/5 M-F w/JLAB Holidays ReBaseline | PROCUREMENT<$50K 60 | 21,669.9 | ELOUADRHIRI L | 1 | 1 | LATIFA E |  |  | 24271117 | D | 4211 | Phil | 12-024 | 13-002F |  | 13-015 | PR |  |  | PE | 14-001 |
| 242751280 |  | Torus - Downstream Hex - VJ final design and Drafting | 13d | 2013-11-25 | 2013-12-13 | 242751275 FS-14d | 91d | 0d | 8/5 M-F w/JLAB Holidays ReBaseline | MECH DES [40 h]; MECH ENG [40 h] | 5,038.8 | ELOUADRHIRI L | 1 | 1 | LATIFA E |  |  | 24271215 | H | 4211 | Phil | 12-024 | 13-002F | EJ | 13-015 | PR |  |  |  | 14-001 |
| 242751290 |  | Torus - Downstream Hex Assembly Parts Procurement | 102d | 2013-11-25 | 2014-04-30 | 242751285 FS-32d | 91d | 47d | 8/5 M-F w/JLAB Holidays ReBaseline | PROCUREMENT<$50K 60; PROCUREMENT>$50K 69 | 74,429.92 | ELOUADRHIRI L | 1 | 1 | LATIFA E |  |  | 24271219 | D | 4211 | Phil | 12-024 | 13-002F |  | 13-015 | PR |  |  | EV | 14-001 |
| 242751170 |  | Torus - Cold Hub - Hub shield final drafting | 22d | 2013-12-02 | 2014-01-10 | 242751165a, 242751165 | 70d | 0d | 8/5 M-F w/JLAB Holidays ReBaseline | MECH ENG [40 h] | 2,986.8 | ELOUADRHIRI L | 1 | 1 | LATIFA E |  |  | 24271150 | H | 4211 | Phil | 12-024 | 13-002F | EJ | 13-015 | PR |  |  |  | 14-001 |
| 242751235 |  | Torus - Upstream Hex Assembly Parts Procurement Prep | 29d | 2013-12-02 | 2014-01-22 | 242751230 FS-25d | 59d | 0d | 8/5 M-F w/JLAB Holidays ReBaseline | MECH ENG [40 h] | 2,986.8 | ELOUADRHIRI L | 1 | 1 | LATIFA E |  |  | 24271197 | H | 4211 | Phil | 12-024 | 13-002F | EJ | 13-015 | PR |  |  |  | 14-001 |
| 242751245 |  | Torus - Recooler Procurement Prep | 23d | 2013-12-02 | 2014-01-13 | 242751210 | 105d | 0d | 8/5 M-F w/JLAB Holidays ReBaseline | MECH ENG [40 h] | 2,986.8 | ELOUADRHIRI L | 1 | 1 | LATIFA E |  |  | 24271199 | H | 4211 | Phil | 12-024 | 13-002F | EJ | 13-015 | PR |  |  |  | 14-001 |
| 242751360 |  | Torus - Main Cold mass support system - Attachment to Floor Engineering | 15d | 2013-12-12 | 2014-01-13 | 242751355a FS+30d, 242751355 FS+30d | 25d | 0d | 8/5 M-F w/JLAB Holidays ReBaseline | MECH ENG [120 h] | 8,960.4 | ELOUADRHIRI L | 1 | 1 | LATIFA E |  |  | 24271255 | H | 4211 | Phil | 12-024 | 13-002F | EJ | 13-015 | PR |  |  |  | 14-001 |
| 242751285 |  | Torus - Downstream Hex Assembly Parts Procurement Prep | 19d | 2013-12-16 | 2014-01-22 | 242751280 | 91d | 0d | 8/5 M-F w/JLAB Holidays ReBaseline | MECH ENG [40 h] | 2,986.8 | ELOUADRHIRI L | 1 | 1 | LATIFA E |  |  | 24271217 | H | 4211 | Phil | 12-024 | 13-002F | EJ | 13-015 | PR |  |  |  | 14-001 |
| 242751390 |  | Torus - Installation Design - Develop Installation Tooling Design | 41d | 2014-01-02 | 2014-02-28 | 242751365 FS-22d | 25d | 0d | 8/5 M-F w/JLAB Holidays ReBaseline | MECH ENG [160 h] | 11,947.2 | ELOUADRHIRI L | 1 | 1 | LATIFA E |  |  | 24271280 | S | 4211 | Phil | 12-024 | 13-002F | EJ | 13-015 | PR |  |  |  | 14-001 |
| 242751175 |  | Torus - Cold Hub Procurement Prep | 34d | 2014-01-13 | 2014-02-28 | 242751170, 242751150 | 70d | 0d | 8/5 M-F w/JLAB Holidays ReBaseline | MECH ENG [40 h] | 2,986.8 | ELOUADRHIRI L | 1 | 1 | LATIFA E |  |  | 24271152 | H | 4211 | Phil | 12-024 | 13-002F | EJ | 13-015 | PR |  |  |  | 14-001 |
| 242751250 |  | Torus - Recooler Procurement | 62d | 2014-01-14 | 2014-04-10 | 242751245 | 105d | 55d | 8/5 M-F w/JLAB Holidays ReBaseline | PROCUREMENT<$50K 60; PROCUREMENT>$50K 69 | 66,400.7 | ELOUADRHIRI L | 1 | 1 | LATIFA E |  |  | 24271200 | D | 4211 | Phil | 12-024 | 13-002F |  | 13-015 | PR |  |  | EV | 14-001 |
| 242751365 |  | Torus - Main Cold mass support system - Attachment to Floor Modeling and Drafting | 14d | 2014-01-14 | 2014-02-03 | 242751360 | 25d | 0d | 8/5 M-F w/JLAB Holidays ReBaseline | MECH ENG [120 h] | 8,960.4 | ELOUADRHIRI L | 1 | 1 | LATIFA E |  |  | 24271260 | H | 4211 | Phil | 12-024 | 13-002F | EJ | 13-015 | PR |  |  |  | 14-001 |
| 242751315 |  | Torus - Supply-Return Header to DS ring - Modeling | 25d | 2014-01-17 | 2014-02-21 | 242751280 FF+16d, 242751280 FS+16d | 145d | 0d | 8/5 M-F w/JLAB Holidays ReBaseline | MECH ENG [40 h] | 2,986.8 | ELOUADRHIRI L | 1 | 1 | LATIFA E |  |  | 24271226 | H | 4211 | Phil | 12-024 | 13-002F | EJ | 13-015 | PR |  |  |  | 14-001 |
| 242751320 |  | Torus - Supply-Return Header to DS ring - Piping flexibility analysis | 25d | 2014-01-17 | 2014-02-21 | 242751315 FS-25d | 145d | 0d | 8/5 M-F w/JLAB Holidays ReBaseline | MECH ENG [40 h] | 2,986.8 | ELOUADRHIRI L | 1 | 1 | LATIFA E |  |  | 24271227 | H | 4211 | Phil | 12-024 | 13-002F | EJ | 13-015 | PR |  |  |  | 14-001 |
| 242751240 |  | Torus - Upstream Hex Assembly Parts Procurement | 102d | 2014-01-23 | 2014-06-16 | 242751235 | 59d | 9d | 8/5 M-F w/JLAB Holidays ReBaseline | PROCUREMENT<$50K 60; PROCUREMENT>$50K 69 | 101,618.42 | ELOUADRHIRI L | 1 | 1 | LATIFA E |  |  | 24271198 | D | 4211 | Phil | 12-024 | 13-002F |  | 13-015 | PR |  |  | EV | 14-001 |
| 242751395 |  | Torus - Installation Design - Model Installation Tooling | 20d | 2014-02-03 | 2014-02-28 | 242751390 FS-20d | 25d | 0d | 8/5 M-F w/JLAB Holidays ReBaseline | MECH ENG [160 h] | 11,947.2 | ELOUADRHIRI L | 1 | 1 | LATIFA E |  |  | 24271285 | S | 4211 | Phil | 12-024 | 13-002F | EJ | 13-015 | PR |  |  |  | 14-001 |
| 242751400 |  | Torus - Installation Design - Analyze Installation Tooling | 30d | 2014-02-03 | 2014-03-14 | 242751395 FS-20d | 25d | 0d | 8/5 M-F w/JLAB Holidays ReBaseline | MECH ENG [80 h] | 5,973.6 | ELOUADRHIRI L | 1 | 1 | LATIFA E |  |  | 24271290 | H | 4211 | Phil | 12-024 | 13-002F | EJ | 13-015 | PR |  |  |  | 14-001 |

| ID | WBS | Activity | Duration | Start | Finish | Predecessors | Total float | Free float | Calendar | Resources | Cost | Original Activity ID Rebaseline | RESP - Responsibility | STRT%COMP for CM EVM | FNSH%COMP for CM EVM | EVMS Reporting Codes | CAM RESPONSIBLE | 12 GEV MAJOR PROCUREMENT CATAGORY | Phil Dev | CR 12-024 | CR 13-002 | BOE Labor | CR 13-015 | Post Rebaseline | CR 14-001 | BOE Procurement | CR 13-014 | ReBaseline Actuals Adjustment |
| --- | --- | --- | --- | --- | --- | --- | --- | --- | --- | --- | --- | --- | --- | --- | --- | --- | --- | --- | --- | --- | --- | --- | --- | --- | --- | --- | --- | --- |
| 242751370 |  | Torus - CM Support Assembly Parts Procurement Prep | 29d | 2014-02-04 | 2014-03-14 | 242751365 | 88d | 0d | 8/5 M-F w/JLAB Holidays ReBaseline | MECH ENG [40 h] | 2,986.8 | 24271262 | ELOUADRHIRI L | 1 | 1 | H | LATIFA E | 4211 | Phil | 12-024 | 13-002F | EJ | 13-015 | PR | 14-001 |  |  |  |
| 242751380 |  | Torus - Torus Support to Hall floor Assembly Procurement Prep | 23d | 2014-02-06 | 2014-03-10 | 242751365 FS+2d | 89d | 0d | 8/5 M-F w/JLAB Holidays ReBaseline | MECH ENG [40 h] | 2,986.8 | 24271265 | ELOUADRHIRI L | 1 | 1 | H | LATIFA E | 4211 | Phil | 12-024 | 13-002F | EJ | 13-015 | PR | 14-001 |  |  |  |
| 242751255 |  | Torus - Upstream Hex MLI Procurement Prep | 20d | 2014-02-10 | 2014-03-07 | 242751225 FS+41d | 184d | 0d | 8/5 M-F w/JLAB Holidays ReBaseline | MECH ENG [40 h] | 2,986.8 | 24271201 | ELOUADRHIRI L | 1 | 1 | H | LATIFA E | 4211 | Phil | 12-024 | 13-002F | EJ | 13-015 | PR | 14-001 |  |  |  |
| 242751295 |  | Torus - Downstream Hex MLI Procurement Prep | 20d | 2014-02-10 | 2014-03-07 | 242751275 FS+30d | 184d | 0d | 8/5 M-F w/JLAB Holidays ReBaseline | MECH ENG [40 h] | 2,986.8 | 24271221 | ELOUADRHIRI L | 1 | 1 | H | LATIFA E | 4211 | Phil | 12-024 | 13-002F | EJ | 13-015 | PR | 14-001 |  |  |  |
| 242751305 |  | Torus - Misc Hex MLI Procurement Prep | 20d | 2014-02-10 | 2014-03-07 | 242751275 FS+30d | 184d | 0d | 8/5 M-F w/JLAB Holidays ReBaseline | MECH ENG [40 h] | 2,986.8 | 24271224 | ELOUADRHIRI L | 1 | 1 | H | LATIFA E | 4211 | Phil | 12-024 | 13-002F | EJ | 13-015 | PR | 14-001 |  |  |  |
| 242751325 |  | Torus - Supply-Return Header to DS ring - Modeling/Drafting | 15d | 2014-02-24 | 2014-03-14 | 242751320 | 145d | 0d | 8/5 M-F w/JLAB Holidays ReBaseline | MECH DES [80 h] | 4,104 | 24271230 | ELOUADRHIRI L | 1 | 1 | H | LATIFA E | 4211 | Phil | 12-024 | 13-002F | EJ | 13-015 | PR | 14-001 |  |  |  |
| 242751180 |  | Torus - Cold Hub Procurement | 64d | 2014-03-03 | 2014-05-30 | 242751175 | 70d | 26d | 8/5 M-F w/JLAB Holidays ReBaseline | PROCUREMENT<$50K 60 | 19,791.84 | 24271154 | ELOUADRHIRI L | 1 | 1 | D | LATIFA E | 4211 | Phil | 12-024 | 13-002F |  | 13-015 | PR | 14-001 | EV |  |  |
| 242751415 |  | Torus - Installation Design - Develop procedures and safety documentation | 26d | 2014-03-03 | 2014-04-07 | 242751390 | 108d | 58d | 8/5 M-F w/JLAB Holidays ReBaseline | MECH ENG [372 h] | 27,777.24 | 24271305 | ELOUADRHIRI L | 1 | 1 | S | LATIFA E | 4211 | Phil | 12-024 | 13-002F | EJ | 13-015 | PR | 14-001 |  |  |  |
| 242751300 |  | Torus - Downstream Hex MLI Procurement | 60d | 2014-03-07 | 2014-05-30 | 242751295 FS-1d | 184d | 167d | 8/5 M-F w/JLAB Holidays ReBaseline | PROCUREMENT<$50K 60 | 6,191.4 | 24271222 | ELOUADRHIRI L | 1 | 1 | D | LATIFA E | 4211 | Phil | 12-024 | 13-002F |  | 13-015 | PR | 14-001 | EV |  |  |
| 242751260 |  | Torus - Upstream Hex MLI Procurement | 59d | 2014-03-10 | 2014-05-30 | 242751255 | 184d | 167d | 8/5 M-F w/JLAB Holidays ReBaseline | PROCUREMENT<$50K 60 | 6,191.4 | 24271202 | ELOUADRHIRI L | 1 | 1 | D | LATIFA E | 4211 | Phil | 12-024 | 13-002F |  | 13-015 | PR | 14-001 | EV |  |  |
| 242751310 |  | Torus - Misc Hex MLI Procurement | 59d | 2014-03-10 | 2014-05-30 | 242751305 | 184d | 167d | 8/5 M-F w/JLAB Holidays ReBaseline | PROCUREMENT<$50K 60 | 6,191.4 | 24271225 | ELOUADRHIRI L | 1 | 1 | D | LATIFA E | 4211 | Phil | 12-024 | 13-002F |  | 13-015 | PR | 14-001 | EV |  |  |
| 242751385 |  | Torus - Torus Support to Hall floor Assembly Procurement | 58d | 2014-03-11 | 2014-05-30 | 242751380 | 89d | 64d | 8/5 M-F w/JLAB Holidays ReBaseline | PROCUREMENT<$50K 60; PROCUREMENT>$50K 69 | 77,392.5 | 24271266 | ELOUADRHIRI L | 1 | 1 | D | LATIFA E | 4211 | Phil | 12-024 | 13-002F |  | 13-015 | PR | 14-001 | EV |  |  |
| 242751330 |  | Torus - Supply-Return Header Procurement Prep | 35d | 2014-03-17 | 2014-05-02 | 242751325 | 145d | 0d | 8/5 M-F w/JLAB Holidays ReBaseline | MECH ENG [40 h] | 2,986.8 | 24271232 | ELOUADRHIRI L | 1 | 1 | H | LATIFA E | 4211 | Phil | 12-024 | 13-002F | EJ | 13-015 | PR | 14-001 |  |  |  |
| 242751375 |  | Torus - CM Support Assembly Parts Procurement | 75d | 2014-03-17 | 2014-06-30 | 242751370 | 88d | 51d | 8/5 M-F w/JLAB Holidays ReBaseline | PROCUREMENT<$50K 60; PROCUREMENT>$50K 69 | 68,105.4 | 24271264 | ELOUADRHIRI L | 1 | 1 | D | LATIFA E | 4211 | Phil | 12-024 | 13-002F |  | 13-015 | PR | 14-001 | EV |  |  |
| 242751405 |  | Torus - Installation Design - Installation Tooling Drafting | 15d | 2014-03-17 | 2014-04-04 | 242751400 | 25d | 0d | 8/5 M-F w/JLAB Holidays ReBaseline | MECH DES [120 h] | 6,156 | 24271295 | ELOUADRHIRI L | 1 | 1 | H | LATIFA E | 4211 | Phil | 12-024 | 13-002F | EJ | 13-015 | PR | 14-001 |  |  |  |
| 242751410 |  | Torus - Installation Design - Develop Scaffolding Design | 10d | 2014-04-07 | 2014-04-18 | 242751405 | 45d | 20d | 8/5 M-F w/JLAB Holidays ReBaseline | MECH DES [80 h] | 4,104 | 24271300 | ELOUADRHIRI L | 1 | 1 | H | LATIFA E | 4211 | Phil | 12-024 | 13-002F | EJ | 13-015 | PR | 14-001 |  |  |  |
| 242751420 |  | Torus - Installation Parts Procurement Prep | 26d | 2014-04-07 | 2014-05-12 | 242751405, 242751410 FS-30d | 25d | 0d | 8/5 M-F w/JLAB Holidays ReBaseline | MECH ENG [40 h] | 2,986.8 | 24271310 | ELOUADRHIRI L | 1 | 1 | H | LATIFA E | 4211 | Phil | 12-024 | 13-002F | EJ | 13-015 | PR | 14-001 |  |  |  |
| 242751335 |  | Torus - Supply-Return Header Procurement | 40d | 2014-05-05 | 2014-06-30 | 242751330 | 145d | 128d | 8/5 M-F w/JLAB Holidays ReBaseline | PROCUREMENT<$50K 60 | 8,255.2 | 24271234 | ELOUADRHIRI L | 1 | 1 | D | LATIFA E | 4211 | Phil | 12-024 | 13-002F |  | 13-015 | PR | 14-001 | EV |  |  |
| 242751440 |  | Torus - Installation Parts Procurement (90K Accounted for Cryo Jumpers) | 77d | 2014-05-13 | 2014-08-29 | 242751420 | 25d | 0d | 8/5 M-F w/JLAB Holidays ReBaseline | PROCUREMENT<$50K 60; PROCUREMENT>$50K 69 | 185,742 | 24271315 | ELOUADRHIRI L | 1 | 1 | D | LATIFA E | 4211 | Phil | 12-024 | 13-002F |  | 13-015 | PR | 14-001 | EV |  |  |
| 242751010LOE |  | Torus - Engineering Oversight FY15 | 15d | 2014-10-01 | 2014-10-21 | 242751005LOE | 420d | 0d | 8/5 M-F w/JLAB Holidays ReBaseline | SR STAFF [190 h] | 22,860.8 | 24271010LOE | ELOUADRHIRI L | 1 | 1 | E | LATIFA E | 4211 | Phil | 12-024 | 13-002F | EJ | 13-015 | PR | 14-001 |  |  |  |
|  | 6 | **1.4.2.7.6 TORUS CRYOGENICS** |  | 2013-08-30 | 2015-03-30 |  |  |  |  |  |  |  |  |  |  |  |  |  |  |  |  |  |  |  |  |  |  |  |
|  | 1 | **1.4.2.7.6.1 CRYO DISTRIBUTION CAN** |  | 2013-08-30 | 2014-08-29 |  |  |  |  |  |  |  |  |  |  |  |  |  |  |  |  |  |  |  |  |  |  |  |
| 142761000 |  | Re-Baseline Actuals Adjustment | 1d | 2013-08-30 | 2013-08-30 | 9-130M FS+227d | 20d |  |  | PROCUREMENT>$50K 69 NO ESCALATION | 22,530.01 |  | ELOUADRHIRI L | 1 | 1 |  | LATIFA E |  |  |  |  |  |  |  |  |  | 13-014 | ADJ |
| 242761000 |  | Torus - Distribution Can - Drafting Mechanical | 11d | 2013-09-03 | 2013-09-17 | 9-130M FS+228d | 153d | 0d | 8/5 M-F w/JLAB Holidays ReBaseline | MECH DES [88 h] | 4,374.48 | 24271350 | ELOUADRHIRI L | 1 | 1 | S | LATIFA E | 4211 | Phil | 12-024 | 13-002F | EJ | 13-015 | PR |  |  |  |  |
| 242761005 |  | Torus - Distribution Can - Drafting Structural | 8d | 2013-09-18 | 2013-09-27 | 242761000 | 153d | 0d | 8/5 M-F w/JLAB Holidays ReBaseline | MECH DES [64 h] | 3,181.44 | 24271350 | ELOUADRHIRI L | 1 | 1 | S | LATIFA E | 4211 | Phil | 12-024 | 13-002F | EJ | 13-015 | PR |  |  |  |  |
| 242761010 |  | Torus - Distribution Can - ProjectMgt FY13 | 1d | 2013-09-30 | 2013-09-30 | 242761005 | 153d | 0d | 8/5 M-F w/JLAB Holidays ReBaseline | MECH ENG [7.69 h] | 556.45 | 24271350 | ELOUADRHIRI L | 1 | 1 | S | LATIFA E | 4211 | Phil | 12-024 | 13-002F | EJ | 13-015 | PR |  |  |  |  |
| 242761010a |  | Torus - Distribution Can - ProjectMgt FY14 | 12d | 2013-10-01 | 2013-10-16 | 242761005, 242761010 | 153d | 0d | 8/5 M-F w/JLAB Holidays ReBaseline | MECH ENG [92.31 h] | 6,892.79 | 24271350 | ELOUADRHIRI L | 1 | 1 | S | LATIFA E | 4211 | Phil | 12-024 | 13-002F | EJ | 13-015 | PR | 14-001 |  |  |  |
| 242761015 |  | Torus - Distribution Can - QA | 13d | 2013-10-17 | 2013-11-04 | 242761010a, 242761010 | 153d | 0d | 8/5 M-F w/JLAB Holidays ReBaseline | MECH ENG [104 h] | 7,765.68 | 24271350 | ELOUADRHIRI L | 1 | 1 | S | LATIFA E | 4211 | Phil | 12-024 | 13-002F | EJ | 13-015 | PR | 14-001 |  |  |  |
| 242761020 |  | Torus - Distribution Can - Write Specs | 15d | 2013-11-05 | 2013-11-25 | 242761015 | 153d | 0d | 8/5 M-F w/JLAB Holidays ReBaseline | MECH ENG [120 h] | 8,960.4 | 24271350 | ELOUADRHIRI L | 1 | 1 | S | LATIFA E | 4211 | Phil | 12-024 | 13-002F | EJ | 13-015 | PR | 14-001 |  |  |  |
| 242761025 |  | Torus - Distribution Can - Bid and select vendor | 40d | 2013-11-26 | 2014-02-04 | 242761020 | 153d | 0d | 8/5 M-F w/JLAB Holidays ReBaseline | MECH ENG [80 h] | 5,973.6 | 24271350 | ELOUADRHIRI L | 1 | 1 | S | LATIFA E | 4211 | Phil | 12-024 | 13-002F | EJ | 13-015 | PR | 14-001 |  |  |  |
| 242761030 |  | Torus - Cryogenic Distribution Can Procurement | 128d | 2014-03-03 | 2014-08-29 | 242761025 FS+18d | 153d | 0d | 8/5 M-F w/JLAB Holidays ReBaseline | PROCUREMENT<$50K 60; PROCUREMENT>$50K 69 | 372,976.13 | 24271355 | ELOUADRHIRI L | 1 | 1 | D | LATIFA E | 4211 | Phil | 12-024 | 13-002F |  | 13-015 | PR | 14-001 | PE |  |  |

| ID | WBS | Activity | Duration | Start | Finish | Predecessors | Total float | Free float | Calendar | Resources | Cost | RESP - Responsibility | STRT%COMP for CM EVM | FNSH%COMP for CM EVM | CAM RESPONSIBLE | CR 13-014 | ReBaseline Actuals Adjustment | Original Activity ID Rebaseline | EVMS Reporting Codes | 12 GEV MAJOR PROCUREMENT CATAGORY | Phil Dev | CR 12-024 | CR 13-002 | BOE Labor | CR 13-015 | Post Rebaseline | CR 14-001 | BOE Procurement |
| --- | --- | --- | --- | --- | --- | --- | --- | --- | --- | --- | --- | --- | --- | --- | --- | --- | --- | --- | --- | --- | --- | --- | --- | --- | --- | --- | --- | --- |
|  | 2 | **1.4.2.7.6.2 CRYO CONTROL CAN** |  | 2013-08-30 | 2015-03-30 |  |  |  |  |  |  |  |  |  |  |  |  |  |  |  |  |  |  |  |  |  |  |  |
| 142762000 |  | Re-Baseline Actuals Adjustment | 1d | 2013-08-30 | 2013-08-30 | 9-130M FS+227d | 20d |  |  | PROCUREMENT>$50K 69 NO ESCALATION | 4,010.76 | ELOUADRHIRI L | 1 | 1 | LATIFA E | 13-014 | ADJ |  |  |  |  |  |  |  |  |  |  |  |
| 242762000 |  | Torus - Cryogenic Tower - Mechanical Engineering FY13 | 20d | 2013-09-03 | 2013-09-30 | 9-130M FS+228d | 38d | 0d | 8/5 M-F w/JLAB Holidays ReBaseline | MECH ENG [160 h] | 11,577.6 | ELOUADRHIRI L | 1 | 1 | LATIFA E |  |  | 24271360 | S | 4211 | Phil | 12-024 | 13-002F | EJ | 13-015 | PR |  |  |
| 242762000a |  | Torus - Cryogenic Tower - Mechanical Engineering FY14 | 55d | 2013-10-01 | 2013-12-18 | 9-130M FS+228d, 242762000 | 38d | 0d | 8/5 M-F w/JLAB Holidays ReBaseline | MECH ENG [440 h] | 32,854.8 | ELOUADRHIRI L | 1 | 1 | LATIFA E |  |  | 24271360 | S | 4211 | Phil | 12-024 | 13-002F | EJ | 13-015 | PR | 14-001 |  |
| 242762005 |  | Torus - Cryogenic Tower - Structural Engineering | 10d | 2013-12-19 | 2014-01-13 | 242762000a, 242762000 | 38d | 0d | 8/5 M-F w/JLAB Holidays ReBaseline | MECH ENG [80 h] | 5,973.6 | ELOUADRHIRI L | 1 | 1 | LATIFA E |  |  | 24271360 | S | 4211 | Phil | 12-024 | 13-002F | EJ | 13-015 | PR | 14-001 |  |
| 242762010 |  | Torus - Cryogenic Tower - Electrical/Instrumentation Engineering | 5d | 2014-01-14 | 2014-01-21 | 242762005 | 38d | 0d | 8/5 M-F w/JLAB Holidays ReBaseline | ELEC ENG [40 h] | 3,005.2 | ELOUADRHIRI L | 1 | 1 | LATIFA E |  |  | 24271360 | S | 4211 | Phil | 12-024 | 13-002F | EJ | 13-015 | PR | 14-001 |  |
| 242762015 |  | Torus - Cryogenic Tower - Drafting Mechanical | 80d | 2014-01-22 | 2014-05-13 | 242762010 | 38d | 0d | 8/5 M-F w/JLAB Holidays ReBaseline | MECH DES [640 h] | 32,832 | ELOUADRHIRI L | 1 | 1 | LATIFA E |  |  | 24271360 | S | 4211 | Phil | 12-024 | 13-002F | EJ | 13-015 | PR | 14-001 |  |
| 242762020 |  | Torus - Cryogenic Tower - Drafting Structural | 15d | 2014-05-14 | 2014-06-04 | 242762015 | 38d | 0d | 8/5 M-F w/JLAB Holidays ReBaseline | MECH DES [120 h] | 6,156 | ELOUADRHIRI L | 1 | 1 | LATIFA E |  |  | 24271360 | S | 4211 | Phil | 12-024 | 13-002F | EJ | 13-015 | PR | 14-001 |  |
| 242762025 |  | Torus - Cryogenic Tower - ProjectMgt | 10d | 2014-06-05 | 2014-06-18 | 242762020 | 38d | 0d | 8/5 M-F w/JLAB Holidays ReBaseline | MECH ENG [80 h] | 5,973.6 | ELOUADRHIRI L | 1 | 1 | LATIFA E |  |  | 24271360 | S | 4211 | Phil | 12-024 | 13-002F | EJ | 13-015 | PR | 14-001 |  |
| 242762030 |  | Torus - Cryogenic Tower - QA | 15d | 2014-06-19 | 2014-07-10 | 242762025 | 38d | 0d | 8/5 M-F w/JLAB Holidays ReBaseline | MECH ENG [120 h] | 8,960.4 | ELOUADRHIRI L | 1 | 1 | LATIFA E |  |  | 24271360 | S | 4211 | Phil | 12-024 | 13-002F | EJ | 13-015 | PR | 14-001 |  |
| 242762035 |  | Torus - Cryogenic Tower - Write Specs | 15d | 2014-07-11 | 2014-07-31 | 242762030 | 38d | 0d | 8/5 M-F w/JLAB Holidays ReBaseline | MECH ENG [120 h] | 8,960.4 | ELOUADRHIRI L | 1 | 1 | LATIFA E |  |  | 24271360 | S | 4211 | Phil | 12-024 | 13-002F | EJ | 13-015 | PR | 14-001 |  |
| 242762040 |  | Torus - Cryogenic Tower - Bid and select vendor | 40d | 2014-08-01 | 2014-09-26 | 242762035 | 38d | 0d | 8/5 M-F w/JLAB Holidays ReBaseline | MECH ENG [80 h] | 5,973.6 | ELOUADRHIRI L | 1 | 1 | LATIFA E |  |  | 24271360 | S | 4211 | Phil | 12-024 | 13-002F | EJ | 13-015 | PR | 14-001 |  |
| 242762045 |  | Torus - Cryogenic Tower Procurement | 120d | 2014-09-29 | 2015-03-30 | 242762040 | 38d | 0d | 8/5 M-F w/JLAB Holidays ReBaseline | PROCUREMENT<$50K 60 NO ESCALATION FY15; PROCUREMENT>$50K 69 NO ESCALATION FY15 | 372,976.13 | ELOUADRHIRI L | 1 | 1 | LATIFA E |  |  | 24271365 | D | 4211 | Phil | 12-024 | 13-002F |  | 13-015 | PR | 14-001 | PE |
|  | 7 | **1.4.2.7.7 TORUS INSTUMENTATION AND CONTROL** |  | 2013-08-30 | 2015-05-06 |  |  |  |  |  |  |  |  |  |  |  |  |  |  |  |  |  |  |  |  |  |  |  |
|  | 1 | **1.4.2.7.7.1 TORUS INSTUMENTATION AND CONTROL** |  | 2013-08-30 | 2015-05-06 |  |  |  |  |  |  |  |  |  |  |  |  |  |  |  |  |  |  |  |  |  |  |  |
| 142771000 |  | Re-Baseline Actuals Adjustment | 1d | 2013-08-30 | 2013-08-30 | 9-130M FS+227d | 20d |  |  | PROCUREMENT>$50K 69 NO ESCALATION | 39,181.6 | ELOUADRHIRI L | 1 | 1 | LATIFA E | 13-014 | ADJ |  |  |  |  |  |  |  |  |  |  |  |
| 242771010 |  | Torus - Instrumentation Sensors Procurement | 60d | 2013-09-03 | 2013-11-25 | 9-130M FS+228d | 142d | 97d | 8/5 M-F w/JLAB Holidays ReBaseline | PROCUREMENT<$50K 60 NO ESCALATION FY14; PROCUREMENT>$50K 69 NO ESCALATION FY14 | 145,500 | ELOUADRHIRI L | 1 | 1 | LATIFA E |  |  | 24271330 | D | 4211 | Phil | 12-024 | 13-002F |  | 13-015 | PR |  | PE |
| 242771000 |  | Torus - Instrumentation Controls Design | 55d | 2013-10-02 | 2013-12-19 | 9-140M FS+1d | 236d | 0d | 8/5 M-F w/JLAB Holidays ReBaseline | ELEC ENG [36.67 h]; ELEC DES [366.66 h] | 22,473.91 | ELOUADRHIRI L | 1 | 1 | LATIFA E |  |  | 24271322 | S | 4211 | Phil | 12-024 | 13-002F | EJ | 13-015 | PR | 14-001 |  |
| 242771005 |  | Torus - Instrumentation Magnet Protection System Design | 120d | 2013-12-20 | 2014-06-19 | 242771000 | 236d | 71d | 8/5 M-F w/JLAB Holidays ReBaseline | ELEC ENG [240 h]; ELEC DES [1400 h] | 93,323.2 | ELOUADRHIRI L | 1 | 1 | LATIFA E |  |  | 24271323 | S | 4211 | Phil | 12-024 | 13-002F | EJ | 13-015 | PR | 14-001 |  |
| 242771015 |  | Torus - Instrumentation Controls Procurement Prep | 5d | 2014-10-01 | 2014-10-07 | 242771000, 9-155M | 55d | 0d | 8/5 M-F w/JLAB Holidays ReBaseline | ELEC ENG [40 h] | 3,005.2 | ELOUADRHIRI L | 1 | 1 | LATIFA E |  |  | 24271335 | H | 4211 | Phil | 12-024 | 13-002F | EJ | 13-015 | PR | 14-001 |  |
| 242771025 |  | Torus - Instrumentation Magnet Protection System Procurement Prep | 5d | 2014-10-01 | 2014-10-07 | 9-155M, 242771005 | 165d | 0d | 8/5 M-F w/JLAB Holidays ReBaseline | ELEC ENG [40 h] | 3,005.2 | ELOUADRHIRI L | 1 | 1 | LATIFA E |  |  | 24271341 | H | 4211 | Phil | 12-024 | 13-002F | EJ | 13-015 | PR | 14-001 |  |
| 242771020 |  | Torus - Instrumentation Controls Procurement | 80d | 2014-10-08 | 2015-02-11 | 242771015 | 55d | 0d | 8/5 M-F w/JLAB Holidays ReBaseline | PROCUREMENT<$50K 60 | 36,116.5 | ELOUADRHIRI L | 1 | 1 | LATIFA E |  |  | 24271340 | D | 4211 | Phil | 12-024 | 13-002F |  | 13-015 | PR | 14-001 | PE |
| 242771030 |  | Torus - Instrumentation Magnet Protection System Procurement | 60d | 2014-10-08 | 2015-01-13 | 242771025 | 165d | 110d | 8/5 M-F w/JLAB Holidays ReBaseline | PROCUREMENT<$50K 60; PROCUREMENT>$50K 69 | 278,784.3 | ELOUADRHIRI L | 1 | 1 | LATIFA E |  |  | 24271342 | D | 4211 | Phil | 12-024 | 13-002F |  | 13-015 | PR | 14-001 | PE |
| 242771035 |  | Torus - Instrumentation Controls Assembly | 120d | 2014-11-05 | 2015-05-06 | 242771030 FS-150d, 242771020 FS-60d | 55d | 38d | 8/5 M-F w/JLAB Holidays ReBaseline | ELEC ENG [232 h]; ELEC TECH [2464 h] | 133,213.52 | ELOUADRHIRI L | 1 | 1 | LATIFA E |  |  | 24271345 | S | 4211 | Phil | 12-024 | 13-002F | EJ | 13-015 | PR | 14-001 |  |

| ID | WBS | Activity | Duration | Start | Finish | Predecessors | Total float | Free float | Calendar | Resources | Cost | RESP - Responsibility | STRT%COMP for CM EVM | FNSH%COMP for CM EVM | CAM RESPONSIBLE | CR 13-014 | ReBaseline Actuals Adjustment | Original Activity ID Rebaseline | EVMS Reporting Codes | 12 GEV MAJOR PROCUREMENT CATAGORY | CR 12-024 | CR 13-002 | BOE Labor | BOE Expenses | CR 13-015 | Post Rebaseline | CR 14-001 | CR 13-004 | BOE Procurement |
| --- | --- | --- | --- | --- | --- | --- | --- | --- | --- | --- | --- | --- | --- | --- | --- | --- | --- | --- | --- | --- | --- | --- | --- | --- | --- | --- | --- | --- | --- |
|  | 8 | **1.4.2.7.8 SOLENOID MAGNET DESIGN/PARTS** |  | 2013-08-30 | 2015-01-05 |  |  |  |  |  |  |  |  |  |  |  |  |  |  |  |  |  |  |  |  |  |  |  |  |
|  | 1 | **1.4.2.7.8.1 SOLENOID MAGNET DESIGN/PARTS** |  | 2013-08-30 | 2015-01-05 |  |  |  |  |  |  |  |  |  |  |  |  |  |  |  |  |  |  |  |  |  |  |  |  |
| 142781000 |  | Re-Baseline Actuals Adjustment | 1d | 2013-08-30 | 2013-08-30 | 9-130M FS+227d | 20d |  |  | PROCUREMENT>$50K 69 NO ESCALATION | 92,282.59 | ELOUADRHIRI L | 1 | 1 | LATIFA E | 13-014 | ADJ |  |  |  |  |  |  |  |  |  |  |  |  |
| 242781000LOE |  | Solenoid - Technical Support & Oversite FY13 | 20d | 2013-09-03 | 2013-09-30 | 9-130M FS+228d | 58d | 0d | 8/5 M-F w/JLAB Holidays ReBaseline | SR STAFF [220.14 h]; SUPPLIES & MATERIALS | 28,352.94 | ELOUADRHIRI L | 1 | 1 | LATIFA E |  |  | 24272060LOE | E | 4211 | 12-024 | 13-002F | EJ | EJ | 13-015 | PR |  |  |  |
| 242781005LOE |  | Solenoid - Technical Support & Oversite FY14 | 247d | 2013-10-01 | 2014-09-30 | 242781000LOE | 58d | 0d | 8/5 M-F w/JLAB Holidays ReBaseline | SR STAFF [2700 h]; SUPPLIES & MATERIALS | 360,980.5 | ELOUADRHIRI L | 1 | 1 | LATIFA E |  |  | 24272065LOE | E | 4211 | 12-024 | 13-002F | EJ | EJ | 13-015 | PR | 14-001 |  |  |
| 242781015 |  | Solenoid - Magent Installation Design | 149d | 2013-10-01 | 2014-05-12 | 9-140M | 133d | 0d | 8/5 M-F w/JLAB Holidays ReBaseline | ELEC ENG [200 h]; SCIENTIST [200 h]; SR STAFF [200 h]; MECH DES [800 h]; MECH ENG [400 h] | 125,034 | ELOUADRHIRI L | 1 | 1 | LATIFA E |  |  | 24272110 | S | 4211 |  |  | EJ |  | 13-015 | PR | 14-001 | 13-004 |  |
| 242781025 |  | Solenoid Commissioning - Design & Documentation | 189d | 2014-03-05 | 2014-12-01 | 9-140M FS+100d | 262d | 259d | 8/5 M-F w/JLAB Holidays ReBaseline | SR STAFF [160 h]; MECH ENG [80 h] | 25,224.8 | ELOUADRHIRI L | 1 | 1 | LATIFA E |  |  | 24272400 | S | 4211 |  |  | EJ |  | 13-015 | PR | 14-001 | 13-004 |  |
| 242781020 |  | Solenoid - Magent Installation Procurements | 120d | 2014-05-13 | 2014-10-30 | 242781015 | 133d | 42d | 8/5 M-F w/JLAB Holidays ReBaseline | PROCUREMENT<$50K 60 NO ESCALATION FY15 | 41,276 | ELOUADRHIRI L | 1 | 1 | LATIFA E |  |  | 24272115 | D | 4211 |  |  |  |  | 13-015 | PR | 14-001 | 13-004 | EJ |
| 242781010LOE |  | Solenoid - Technical Support & Oversite FY15 | 59d | 2014-10-01 | 2015-01-05 | 242781005LOE | 683d | 742d | 8/5 M-F w/JLAB Holidays ReBaseline | SUPPLIES & MATERIALS; SR STAFF [486.8 h] | 68,890.78 | ELOUADRHIRI L | 1 | 1 | LATIFA E |  |  | 24272067LOE | E | 4211 | 12-024 | 13-002F | EJ | EJ | 13-015 | PR | 14-001 |  |  |
|  | 9 | **1.4.2.7.9 SOLENOID CRYOGENICS** |  | 2013-08-30 | 2015-07-06 |  |  |  |  |  |  |  |  |  |  |  |  |  |  |  |  |  |  |  |  |  |  |  |  |
|  | 1 | **1.4.2.7.9.1 SOLENOID CRYOGENICS** |  | 2013-08-30 | 2015-07-06 |  |  |  |  |  |  |  |  |  |  |  |  |  |  |  |  |  |  |  |  |  |  |  |  |
| 142791000 |  | Re-Baseline Actuals Adjustment | 1d | 2013-08-30 | 2013-08-30 | 9-130M FS+227d | 20d |  |  | PROCUREMENT>$50K 69 NO ESCALATION | 5,842.93 | ELOUADRHIRI L | 1 | 1 | LATIFA E | 13-014 | ADJ |  |  |  |  |  |  |  |  |  |  |  |  |
| 242791000 |  | Solenoid - Thermal Analysis FY13 | 20d | 2013-09-03 | 2013-09-30 | 9-130M FS+228d | 3d | 0d | 8/5 M-F w/JLAB Holidays ReBaseline | MECH ENG [160 h] | 11,577.6 | ELOUADRHIRI L | 1 | 1 | LATIFA E |  |  | 24272120 | S | 4211 |  |  | EJ |  | 13-015 | PR |  | 13-004 |  |
| 242791000a |  | Solenoid - Thermal Analysis FY14 | 50d | 2013-10-01 | 2013-12-11 | 242791000, 9-130M FS+228d | 3d | 0d | 8/5 M-F w/JLAB Holidays ReBaseline | MECH ENG [400 h] | 29,868 | ELOUADRHIRI L | 1 | 1 | LATIFA E |  |  | 24272120 | S | 4211 |  |  | EJ |  | 13-015 | PR | 14-001 | 13-004 |  |
| 242791005 |  | Solenoid - Process P&Is | 30d | 2013-11-19 | 2014-01-13 | 242791000a FS-15d, 242791000 FS-15d | 3d | 0d | 8/5 M-F w/JLAB Holidays ReBaseline | MECH DES [120 h]; MECH ENG [120 h] | 15,116.4 | ELOUADRHIRI L | 1 | 1 | LATIFA E |  |  | 24272120 | S | 4211 |  |  | EJ |  | 13-015 | PR | 14-001 | 13-004 |  |
| 242791010 |  | Solenoid - Cryogenic Modes of Operation | 15d | 2014-01-14 | 2014-02-04 | 242791005 | 3d | 0d | 8/5 M-F w/JLAB Holidays ReBaseline | MECH ENG [120 h] | 8,960.4 | ELOUADRHIRI L | 1 | 1 | LATIFA E |  |  | 24272120 | S | 4211 |  |  | EJ |  | 13-015 | PR | 14-001 | 13-004 |  |
| 242791020 |  | Solenoid - Evaluation of Process Components | 20d | 2014-02-03 | 2014-02-28 | 242791015 FS-5d | 3d | 0d | 8/5 M-F w/JLAB Holidays ReBaseline | MECH ENG [80 h]; MECH TECH [80 h] | 9,759.2 | ELOUADRHIRI L | 1 | 1 | LATIFA E |  |  | 24272120 | S | 4211 |  |  | EJ |  | 13-015 | PR | 14-001 | 13-004 |  |
| 242791015 |  | Solenoid - PDR | 3d | 2014-02-05 | 2014-02-07 | 242791010 | 3d | 0d | 8/5 M-F w/JLAB Holidays ReBaseline | MECH ENG [24 h] | 1,792.08 | ELOUADRHIRI L | 1 | 1 | LATIFA E |  |  | 24272120 | S | 4211 |  |  | EJ |  | 13-015 | PR | 14-001 | 13-004 |  |
| 242791025 |  | Solenoid - Current Leads | 23d | 2014-03-03 | 2014-04-02 | 242791020 | 3d | 0d | 8/5 M-F w/JLAB Holidays ReBaseline | MECH ENG [92 h]; MECH TECH [92 h] | 11,223.08 | ELOUADRHIRI L | 1 | 1 | LATIFA E |  |  | 24272120 | S | 4211 |  |  | EJ |  | 13-015 | PR | 14-001 | 13-004 |  |
| 242791030 |  | Solenoid - Mechanical Design of the cryogenic can | 120d | 2014-04-03 | 2014-09-22 | 242791025 | 3d | 0d | 8/5 M-F w/JLAB Holidays ReBaseline | MECH ENG [480 h]; MECH TECH [480 h] | 58,555.2 | ELOUADRHIRI L | 1 | 1 | LATIFA E |  |  | 24272120 | S | 4211 |  |  | EJ |  | 13-015 | PR | 14-001 | 13-004 |  |
| 242791035 |  | Solenoid - FDR | 1d | 2014-09-23 | 2014-09-23 | 242791030 | 3d | 0d | 8/5 M-F w/JLAB Holidays ReBaseline | MECH ENG [8 h] | 597.36 | ELOUADRHIRI L | 1 | 1 | LATIFA E |  |  | 24272120 | S | 4211 |  |  | EJ |  | 13-015 | PR | 14-001 | 13-004 |  |
| 242791040 |  | Solenoid Cryogenics - Write Specifications | 15d | 2014-09-24 | 2014-10-14 | 242791035 | 3d | 0d | 8/5 M-F w/JLAB Holidays ReBaseline | MECH ENG [120 h] | 8,960.4 | ELOUADRHIRI L | 1 | 1 | LATIFA E |  |  | 24272125 | D | 4211 |  |  |  | EJ | 13-015 | PR | 14-001 | 13-004 | EJ |
| 242791045 |  | Solenoid Cryogenics - Bid cycle, review and award | 40d | 2014-10-15 | 2014-12-11 | 242791040 | 3d | 0d | 8/5 M-F w/JLAB Holidays ReBaseline | MECH ENG [80 h] | 5,973.6 | ELOUADRHIRI L | 1 | 1 | LATIFA E |  |  | 24272125 | D | 4211 |  |  |  | EJ | 13-015 | PR | 14-001 | 13-004 | EJ |
| 242791050 |  | Solenoid Cryogenics - Procurement | 100d | 2014-12-12 | 2015-05-13 | 242791045 | 3d | 0d | 8/5 M-F w/JLAB Holidays ReBaseline | PROCUREMENT<$50K 60; PROCUREMENT>$50K 69; SUPPLIES & MATERIALS | 347,750.3 | ELOUADRHIRI L | 1 | 1 | LATIFA E |  |  | 24272125 | D | 4211 |  |  |  | EJ | 13-015 | PR | 14-001 | 13-004 | EJ |
| 242791055 |  | Solenoid cryogenics - Installation and Commissioning | 15d | 2015-05-14 | 2015-06-05 | 242791050 | 3d | 0d | 8/5 M-F w/JLAB Holidays ReBaseline | MECH ENG [60 h]; MECH TECH [60 h] | 7,319.4 | ELOUADRHIRI L | 1 | 1 | LATIFA E |  |  | 24272130 | S | 4211 |  |  | EJ | EJ | 13-015 | PR | 14-001 | 13-004 |  |
| 242791060 |  | Solenoid cryogenics - Test of system | 20d | 2015-06-08 | 2015-07-06 | 242791055 | 3d | 0d | 8/5 M-F w/JLAB Holidays ReBaseline | MECH ENG [80 h]; MECH TECH [80 h] | 9,759.2 | ELOUADRHIRI L | 1 | 1 | LATIFA E |  |  | 24272130 | S | 4211 |  |  | EJ | EJ | 13-015 | PR | 14-001 | 13-004 |  |

| ID | WBS | Activity | Duration | Start | Finish | Predecessors | Total float | Free float | Calendar | Resources | Cost | RESP - Responsibility | STRT%COMP for CM EVM | FNSH%COMP for CM EVM | CAM RESPONSIBLE | CR 13-014 | ReBaseline Actuals Adjustment | Original Activity ID Rebaseline | EVMS Reporting Codes | 12 GEV MAJOR PROCUREMENT CATAGORY | CR 12-024 | CR 13-002 | BOE Labor | CR 13-015 | Post Rebaseline | CR 14-001 | BOE Procurement | Activities with Steps |
| --- | --- | --- | --- | --- | --- | --- | --- | --- | --- | --- | --- | --- | --- | --- | --- | --- | --- | --- | --- | --- | --- | --- | --- | --- | --- | --- | --- | --- |
|  | 10 | **1.4.2.7.10 SOLENOID INSTRUMENTATION AND CONTROLS** |  | 2013-08-30 | 2015-02-17 |  |  |  |  |  |  |  |  |  |  |  |  |  |  |  |  |  |  |  |  |  |  |  |
|  | 1 | **1.4.2.7.10.1 SOLENOID INSTRUMENTATION AND CONTROLS** |  | 2013-08-30 | 2015-02-17 |  |  |  |  |  |  |  |  |  |  |  |  |  |  |  |  |  |  |  |  |  |  |  |
| 1427.10000 |  | Re-Baseline Actuals Adjustment | 1d | 2013-08-30 | 2013-08-30 | 9-130M FS+227d | 20d |  |  | PROCUREMENT>$50K 69 NO ESCALATION | 4,331.8 | ELOUADRHIRI L | 1 | 1 | LATIFA E | 13-014 | ADJ |  |  |  |  |  |  |  |  |  |  |  |
| 242710.1015 |  | Solenoid - Instrumentation Controls Design FY13 | 20d | 2013-09-03 | 2013-09-30 | 9-130M FS+228d | 98d | 0d | 8/5 M-F w/JLAB Holidays ReBaseline | ELEC ENG [11.11 h]; ELEC DES [111.11 h] | 6,600 | ELOUADRHIRI L | 1 | 1 | LATIFA E |  |  | 24272168 | S | 4211 | 12-024 | 13-002F | EJ | 13-015 | PR |  |  |  |
| 242710.1015a |  | Solenoid - Instrumentation Controls Design FY14 | 52d | 2013-10-01 | 2013-12-13 | 242710.1015, 9-130M FS+228d | 98d | 0d | 8/5 M-F w/JLAB Holidays ReBaseline | ELEC ENG [28.89 h]; ELEC DES [288.89 h] | 17,706.99 | ELOUADRHIRI L | 1 | 1 | LATIFA E |  |  | 24272168 | S | 4211 | 12-024 | 13-002F | EJ | 13-015 | PR | 14-001 |  |  |
| 242710.1000 |  | Solenoid - Instrumentation Magnet Protection System Design | 120d | 2013-12-16 | 2014-06-13 | 242710.1015, 242710.1015a | 187d | 0d | 8/5 M-F w/JLAB Holidays ReBaseline | ELEC ENG [240 h]; ELEC DES [1400 h] | 93,323.2 | ELOUADRHIRI L | 1 | 1 | LATIFA E |  |  | 24272140 | S | 4211 | 12-024 | 13-002F | EJ | 13-015 | PR | 14-001 |  |  |
| 242710.1020 |  | Solenoid - Instrumentation Controls Procurement Prep | 5d | 2013-12-16 | 2013-12-20 | 242710.1015, 242710.1015a | 98d | 0d | 8/5 M-F w/JLAB Holidays ReBaseline | ELEC ENG [40 h] | 3,005.2 | ELOUADRHIRI L | 1 | 1 | LATIFA E |  |  | 24272170 | H | 4211 | 12-024 | 13-002F | EJ | 13-015 | PR | 14-001 |  |  |
| 242710.1025 |  | Solenoid - Instrumentation Controls Procurement | 79d | 2014-01-02 | 2014-04-23 | 242710.1020 | 98d | 0d | 8/5 M-F w/JLAB Holidays ReBaseline | PROCUREMENT<$50K 60 | 36,116.5 | ELOUADRHIRI L | 1 | 1 | LATIFA E |  |  | 24272175 | D | 4211 | 12-024 | 13-002F |  | 13-015 | PR | 14-001 | EJ |  |
| 242710.1005 |  | Solenoid - Instrumentation Magnet Protection System Procurement Prep | 5d | 2014-06-16 | 2014-06-20 | 242710.1000 | 187d | 0d | 8/5 M-F w/JLAB Holidays ReBaseline | ELEC ENG [40 h] | 3,005.2 | ELOUADRHIRI L | 1 | 1 | LATIFA E |  |  | 24272145 | H | 4211 | 12-024 | 13-002F | EJ | 13-015 | PR | 14-001 |  |  |
| 242710.1030 |  | Solenoid - Instrumentation Controls Assembly | 160d | 2014-06-20 | 2015-02-17 | 242710.1025 FS+40d, 242710.1010 FS-150d | 98d | 95d | 8/5 M-F w/JLAB Holidays ReBaseline | ELEC ENG [232 h]; ELEC TECH [2464 h] | 133,213.52 | ELOUADRHIRI L | 1 | 1 | LATIFA E |  |  | 24272180 | S | 4211 | 12-024 | 13-002F | EJ | 13-015 | PR | 14-001 |  |  |
| 242710.1010 |  | Solenoid - Instrumentation Magnet Protection System Procurement | 60d | 2014-06-23 | 2014-09-16 | 242710.1005 | 187d | 89d | 8/5 M-F w/JLAB Holidays ReBaseline | PROCUREMENT<$50K 60; PROCUREMENT>$50K 69 | 312,923.68 | ELOUADRHIRI L | 1 | 1 | LATIFA E |  |  | 24272150 | D | 4211 | 12-024 | 13-002F |  | 13-015 | PR | 14-001 | EJ |  |
|  | 11 | **1.4.2.7.11 TORUS RISK MITIGATION** |  | 2013-09-03 | 2015-04-09 |  |  |  |  |  |  |  |  |  |  |  |  |  |  |  |  |  |  |  |  |  |  |  |
|  | 1 | **1.4.2.7.11.1 ADDITIONAL FNAL COILS FOR TORUS RISK MITIGATION** |  | 2013-10-01 | 2014-11-26 |  |  |  |  |  |  |  |  |  |  |  |  |  |  |  |  |  |  |  |  |  |  |  |
| 242711.1005 |  | FNAL - Fabricate Prototype CCM | 119d | 2013-10-01 | 2014-03-31 | 242711.4005a FS-25d, 242711.4005b FS-25d, 242711.4005 FS-25d | 58d | 0d | 8/5 M-F w/JLAB Holidays ReBaseline | PROCUREMENT<$50K 60; PROCUREMENT>$50K 69 | 132,222.51 | ELOUADRHIRI L | 1 | 1 | LATIFA E |  |  | 24272180 | D | 4211 | 12-024 | 13-002F | EJ | 13-015 | PR | 14-001 |  |  |
| 242711.1010 |  | FNAL - Fabricate CCM #7 | 288d | 2013-10-01 | 2014-11-26 | 242711.4010 FS-87d, 242711.1000 FS-270d, 242711.1005 FS-119d | 72d | 0d | 8/5 M-F w/JLAB Holidays ReBaseline | PROCUREMENT>$50K 69 NO ESCALATION FY15 | 132,222.51 | ELOUADRHIRI L | 1 | 1 | LATIFA E |  |  | 24272180 | D | 4211 | 12-024 | 13-002F | EJ | 13-015 | PR | 14-001 |  |  |
| 242711.1000 |  | Additional FNAL Oversight | 86d | 2014-07-02 | 2014-10-31 | 24271735LOE | 72d | 0d | 8/5 M-F w/JLAB Holidays ReBaseline | SR STAFF [480 h] | 57,753.6 | ELOUADRHIRI L | 1 | 1 | LATIFA E |  |  | 24272180 | E | 4211 | 12-024 | 13-002F | EJ | 13-015 | PR | 14-001 |  |  |
|  | 2 | **1.4.2.7.11.2 ADDITIONAL COIL CASE AND HARDWARE FOR TORUS RISK MITIGATION** |  | 2013-09-03 | 2013-12-20 |  |  |  |  |  |  |  |  |  |  |  |  |  |  |  |  |  |  |  |  |  |  |  |
| 242711.2005 |  | Vend Fab 1 Set of Additional Hardware for Cryostat (Cold Mass Shiled, OOPS, Axial Support, MLI, Vacuum Jacket) | 77d | 2013-09-03 | 2013-12-20 | 9-130M FS+228d | 453d | 436d | 8/5 M-F w/JLAB Holidays ReBaseline | PROCUREMENT<$50K 60 NO ESCALATION FY14 | 45,350 | ELOUADRHIRI L | 1 | 1 | LATIFA E |  |  | 24272180 | D | 4211 | 12-024 | 13-002F | EJ | 13-015 | PR |  |  |  |
|  | 3 | **1.4.2.7.11.3 COIL LN2 TESTING FOR TORUS RISK MITIGATION** |  | 2013-09-03 | 2014-11-26 |  |  |  |  |  |  |  |  |  |  |  |  |  |  |  |  |  |  |  |  |  |  |  |
| 242711.3000 |  | LN2 TEST - Procurements Preperation FY13 | 20d | 2013-09-03 | 2013-09-30 | 9-130M FS+228d | 110.5d | 0d | 8/5 M-F w/JLAB Holidays ReBaseline | ELEC TECH [18.61 h]; SR STAFF [18.61 h] | 3,016.61 | ELOUADRHIRI L | 1 | 1 | LATIFA E |  |  | 24272180 | S | 4211 | 12-024 | 13-002F | EJ | 13-015 | PR |  |  | ST |
| 242711.3000a |  | LN2 TEST - Procurements Preperation FY14 | 23.5d | 2013-10-01 | 2013-11-01 | 9-130M FS+228d, 242711.3000 | 110.5d | 0d | 8/5 M-F w/JLAB Holidays ReBaseline | ELEC TECH [21.39 h]; SR STAFF [21.39 h] | 3,579.6 | ELOUADRHIRI L | 1 | 1 | LATIFA E |  |  | 24272180 | S | 4211 | 12-024 | 13-002F | EJ | 13-015 | PR | 14-001 |  | ST |
| 242711.3005 |  | LN2 TEST - Preliminary system set up and integration (One coil LN2 Test) Procurements | 40d | 2013-10-01 | 2013-11-26 | 242711.3000 FS-23d, 242711.3000a FS-23d | 121.5d | 63.5d | 8/5 M-F w/JLAB Holidays ReBaseline | PROCUREMENT<$50K 60 | 30,441.05 | ELOUADRHIRI L | 1 | 1 | LATIFA E |  |  | 24272180 | D | 4211 | 12-024 | 13-002F | EJ | 13-015 | PR | 14-001 |  |  |
| 242711.3010 |  | LN2 TEST - Mounting of Q heaters and wiring | 16d | 2013-10-01 | 2013-10-23 | 242711.3000 FS-23d, 242711.3000a FS-23d | 110.5d | 0d | 8/5 M-F w/JLAB Holidays ReBaseline | ELEC TECH [120 h]; SR STAFF [80 h] | 15,264.4 | ELOUADRHIRI L | 1 | 1 | LATIFA E |  |  | 24272180 | S | 4211 | 12-024 | 13-002F | EJ | 13-015 | PR | 14-001 |  | ST |
| 242711.3015 |  | LN2 TEST - Instrumentation general and wiring layout and cabling | 11d | 2013-10-23 | 2013-11-07 | 242711.3010 | 110.5d | 0d | 8/5 M-F w/JLAB Holidays ReBaseline | ELEC TECH [80 h]; SR STAFF [60 h] | 10,978.4 | ELOUADRHIRI L | 1 | 1 | LATIFA E |  |  | 24272180 | S | 4211 | 12-024 | 13-002F | EJ | 13-015 | PR | 14-001 |  | ST |
| 242711.3025 |  | LN2 TEST - Preliminary system set up and integration (One coil LN2 Test) Labor | 29d | 2013-10-23 | 2013-12-05 | 242711.3010 | 116.5d | 58.5d | 8/5 M-F w/JLAB Holidays ReBaseline | ELEC TECH [200 h]; SR STAFF [100 h] | 21,430 | ELOUADRHIRI L | 1 | 1 | LATIFA E |  |  | 24272180 | S | 4211 | 12-024 | 13-002F | EJ | 13-015 | PR | 14-001 |  | ST |
| 242711.3020 |  | LN2 TEST - HV/LV Feedthrough and wirng | 24d | 2013-11-07 | 2013-12-13 | 242711.3015 | 110.5d | 52.5d | 8/5 M-F w/JLAB Holidays ReBaseline | ELEC TECH [200 h]; SR STAFF [80 h] | 19,023.6 | ELOUADRHIRI L | 1 | 1 | LATIFA E |  |  | 24272180 | S | 4211 | 12-024 | 13-002F | EJ | 13-015 | PR | 14-001 |  | ST |
| 242711.3030 |  | LN2 TEST - LN2 Testing of Prototype Coil | 10d | 2014-03-11 | 2014-03-24 | 242711.3005, 242711.3020, 242711.1005 FS-15d, 242711.3025 | 58d | 6d | 8/5 M-F w/JLAB Holidays ReBaseline | ELEC TECH [120 h]; SR STAFF [60 h]; SUPPLIES & MATERIALS | 14,921.8 | ELOUADRHIRI L | 1 | 1 | LATIFA E |  |  | 24272180 | S | 4211 | 12-024 | 13-002F | EJ | 13-015 | PR | 14-001 |  | ST |
| 242711.3035 |  | LN2 TEST - LN2 Testing of CCM #1 | 10d | 2014-04-11 | 2014-04-24 | 242711.3030, 24271695 FS-14d | 45d | 0d | 8/5 M-F w/JLAB Holidays ReBaseline | ELEC TECH [120 h]; SR STAFF [60 h]; SUPPLIES & MATERIALS | 14,921.8 | ELOUADRHIRI L | 1 | 1 | LATIFA E |  |  | 24272180 | S | 4211 | 12-024 | 13-002F | EJ | 13-015 | PR | 14-001 |  | ST |
| 242711.3040 |  | LN2 TEST - LN2 Testing of CCM #2 | 10d | 2014-05-15 | 2014-05-29 | 24271700 FS-11d, 242711.3035 | 37d | 0d | 8/5 M-F w/JLAB Holidays ReBaseline | ELEC TECH [120 h]; SR STAFF [60 h]; SUPPLIES & MATERIALS | 14,921.8 | ELOUADRHIRI L | 1 | 1 | LATIFA E |  |  | 24272180 | S | 4211 | 12-024 | 13-002F | EJ | 13-015 | PR | 14-001 |  | ST |
| 242711.3045 |  | LN2 TEST - LN2 Testing of CCM #3 | 10d | 2014-06-19 | 2014-07-02 | 242711.3040, 24271705 FS-8d | 35d | 0d | 8/5 M-F w/JLAB Holidays ReBaseline | ELEC TECH [120 h]; SR STAFF [60 h]; SUPPLIES & MATERIALS | 14,921.8 | ELOUADRHIRI L | 1 | 1 | LATIFA E |  |  | 24272180 | S | 4211 | 12-024 | 13-002F | EJ | 13-015 | PR | 14-001 |  | ST |
| 242711.3050 |  | LN2 TEST - LN2 Testing of CCM #4 | 10d | 2014-07-28 | 2014-08-08 | 24271710 FS-4d, 242711.3045 | 30d | 0d | 8/5 M-F w/JLAB Holidays ReBaseline | ELEC TECH [120 h]; SR STAFF [60 h]; SUPPLIES & MATERIALS | 14,921.8 | ELOUADRHIRI L | 1 | 1 | LATIFA E |  |  | 24272180 | S | 4211 | 12-024 | 13-002F | EJ | 13-015 | PR | 14-001 |  | ST |
| 242711.3055 |  | LN2 TEST - LN2 Testing of CCM #5 | 10d | 2014-09-02 | 2014-09-15 | 242711.3050, 24271715 | 20d | 0d | 8/5 M-F w/JLAB Holidays ReBaseline | ELEC TECH [120 h]; SR STAFF [60 h]; SUPPLIES & MATERIALS | 14,921.8 | ELOUADRHIRI L | 1 | 1 | LATIFA E |  |  | 24272180 | S | 4211 | 12-024 | 13-002F | EJ | 13-015 | PR | 14-001 |  | ST |
| 242711.3060 |  | LN2 TEST - LN2 Testing of CCM #6 | 10d | 2014-10-01 | 2014-10-14 | 24271720, 242711.3055 | 17d | 0d | 8/5 M-F w/JLAB Holidays ReBaseline | ELEC TECH [120 h]; SR STAFF [60 h]; SUPPLIES & MATERIALS | 14,921.8 | ELOUADRHIRI L | 1 | 1 | LATIFA E |  |  | 24272180 | S | 4211 | 12-024 | 13-002F | EJ | 13-015 | PR | 14-001 |  | ST |
| 242711.3065 |  | LN2 TEST - LN2 Testing of CCM #7 | 10d | 2014-11-13 | 2014-11-26 | 242711.3060, 242711.1010 FS-10d | 72d | 0d | 8/5 M-F w/JLAB Holidays ReBaseline | ELEC TECH [120 h]; SR STAFF [60 h]; SUPPLIES & MATERIALS | 14,921.8 | ELOUADRHIRI L | 1 | 1 | LATIFA E |  |  | 24272180 | S | 4211 | 12-024 | 13-002F | EJ | 13-015 | PR | 14-001 |  | ST |

Notes:
- 242711.3000: Steps: Quench Heaters-Specs; Temp / hall sensors-Specs; Strain gauges-Specs; LV/HV feed through-Specs; QH PSU-Design and spec; Wires, cables and ribbons-Specs; Design of foam box for the test; Plumbing
- 242711.3000a: Steps: Quench Heaters-Specs; Temp / hall sensors-Specs; Strain gauges-Specs; LV/HV feed through-Specs; QH PSU-Design and spec; Wires, cables and ribbons-Specs; Design of foam box for the test; Plumbing
- 242711.3010: Steps: Test of Q Heaters at 77 K; Mounting of Q Heaters to trial coil; Layout of Q heaters wiring; Short test - Coil to GND(Hi Pot, 100V)
- 242711.3015: Steps: Wiring layout; Sensors wiring; Thermal dumps and electrical isolation; Measuring resistances over the actual length; Routing
- 242711.3025: Steps: Room temperature measurement; Set up the calibration for sensors; EHS and safety survey; Test and process control; Set up process and data logging all together at room temperature; Fabricate foam box; Connect plumbing for LN2 and gaseous nitrogen to mixer; Plumb and insulate exhaust lines
- 242711.3020: Steps: wiring the HV and LV feed through; Prepare for the interconnect; Layout the interconnect cable to read out/data logger; De-bugging the cables and check for adequate redundancy
- 242711.3030: Steps: Mounting of Temp /hall sensors; Mounting of Q Heaters; Mounting of strain gauges; Wiring/cable layout and HV/HV feed through wiring to the interconnect; Set up for calibration in the data logger; Set up process and data logging all together at room temperature; Wrap CCM in plastic bag and purge with dry nitrogen; Lift CCM into foam box and Connect instrumentation and plumbing to CCM in box; Monitor Coil temps during test; Disconnect from plumbing & instr; Crane lifted into the shipping crate
- 242711.3035: Steps: Mounting of Temp /hall sensors; Mounting of Q Heaters; Mounting of strain gauges; Wiring/cable layout and HV/HV feed through wiring to the interconnect; Set up for calibration in the data logger; Set up process and data logging all together at room temperature; Wrap CCM in plastic bag and purge with dry nitrogen; Lift CCM into foam box and Connect instrumentation and plumbing to CCM in box; Monitor Coil temps during test; Disconnect from plumbing & instr; Crane lifted into the shipping crate
- 242711.3040: Steps: Mounting of Temp /hall sensors; Mounting of Q Heaters; Mounting of strain gauges; Wiring/cable layout and HV/HV feed through wiring to the interconnect; Set up for calibration in the data logger; Set up process and data logging all together at room temperature; Wrap CCM in plastic bag and purge with dry nitrogen; Lift CCM into foam box and Connect instrumentation and plumbing to CCM in box; Monitor Coil temps during test; Disconnect from plumbing & instr; Crane lifted into the shipping crate
- 242711.3045: Steps: Mounting of Temp /hall sensors; Mounting of Q Heaters; Mounting of strain gauges; Wiring/cable layout and HV/HV feed through wiring to the interconnect; Set up for calibration in the data logger; Set up process and data logging all together at room temperature; Wrap CCM in plastic bag and purge with dry nitrogen; Lift CCM into foam box and Connect instrumentation and plumbing to CCM in box; Monitor Coil temps during test; Disconnect from plumbing & instr; Crane lifted into the shipping crate
- 242711.3050: Steps: Mounting of Temp /hall sensors; Mounting of Q Heaters; Mounting of strain gauges; Wiring/cable layout and HV/HV feed through wiring to the interconnect; Set up for calibration in the data logger; Set up process and data logging all together at room temperature; Wrap CCM in plastic bag and purge with dry nitrogen; Lift CCM into foam box and Connect instrumentation and plumbing to CCM in box; Monitor Coil temps during test; Disconnect from plumbing & instr; Crane lifted into the shipping crate
- 242711.3055: Steps: Mounting of Temp /hall sensors; Mounting of Q Heaters; Mounting of strain gauges; Wiring/cable layout and HV/HV feed through wiring to the interconnect; Set up for calibration in the data logger; Set up process and data logging all together at room temperature; Wrap CCM in plastic bag and purge with dry nitrogen; Lift CCM into foam box and Connect instrumentation and plumbing to CCM in box; Monitor Coil temps during test; Disconnect from plumbing & instr; Crane lifted into the shipping crate
- 242711.3060: Steps: Mounting of Temp /hall sensors; Mounting of Q Heaters; Mounting of strain gauges; Wiring/cable layout and HV/HV feed through wiring to the interconnect; Set up for calibration in the data logger; Set up process and data logging all together at room temperature; Wrap CCM in plastic bag and purge with dry nitrogen; Lift CCM into foam box and Connect instrumentation and plumbing to CCM in box; Monitor Coil temps during test; Disconnect from plumbing & instr; Crane lifted into the shipping crate
- 242711.3065: Steps: Mounting of Temp /hall sensors; Mounting of Q Heaters; Mounting of strain gauges; Wiring/cable layout and HV/HV feed through wiring to the interconnect; Set up for calibration in the data logger; Set up process and data logging all together at room temperature; Wrap CCM in plastic bag and purge with dry nitrogen; Lift CCM into foam box and Connect instrumentation and plumbing to CCM in box; Monitor Coil temps during test; Disconnect from plumbing & instr; Crane lifted into the shipping crate

| ID | WBS | Activity | Type | Duration | Start | Finish | Predecessors | Total float | Free float | Constraint | Calendar | Resources | Cost | Original Activity ID Rebaseline | RESP - Responsibility | STRT%COMP for CM EVM | FNSH%COMP for CM EVM | CAM RESPONSIBLE | 12 GEV MAJOR PROCUREMENT CATAGORY | CR 12-024 | CR 13-002 | BOE Labor | CR 13-015 | Post Rebaseline | CR 14-001 | EVMS Reporting Codes | Milestone Level | CR 08-048 | CR 08-057 | CR 09-022 | CR 07-034 | CR 10-063 | CR 10-069 | CR 10-074 | CR 11-017 | CR 11-026 | CR 11-046 | CR 12-012 | Advance Purchase Plan > 500K | CR 08-016 | CR 08-042 | CR 09-012 | CR 12-036 | CR 12-001 | CR 12-053 | CR 11-025 | CR 13-014 | ReBaseline Actuals Adjustment | CR 13-006 | BOE Expenses | BOE NOTES | Over Under Fixed | BOE Procurement | BOE Adder | Obligated Prior to Rebaseline | Pat's Code | CR 12-054 |
| --- | --- | --- | --- | --- | --- | --- | --- | --- | --- | --- | --- | --- | --- | --- | --- | --- | --- | --- | --- | --- | --- | --- | --- | --- | --- | --- | --- | --- | --- | --- | --- | --- | --- | --- | --- | --- | --- | --- | --- | --- | --- | --- | --- | --- | --- | --- | --- | --- | --- | --- | --- | --- | --- | --- | --- | --- | --- |
|  | 4 | **1.4.2.7.11.4 ADDITIONAL COPPER SSC AND SOLDERING FOR TORUS RISK MITIGATION** |  |  | 2013-09-03 | 2014-02-06 |  |  |  |  |  |  |  |  |  |  |  |  |  |  |  |  |  |  |  |  |  |  |  |  |  |  |  |  |  |  |  |  |  |  |  |  |  |  |  |  |  |  |  |  |  |  |  |  |  |  |  |
| 242711.4005 |  | Solder condutor for Prototype Coil - Procurement |  | 45d | 2013-09-03 | 2013-11-04 | 24271740 FS-60d | 58d | 0d |  | 8/5 M-F w/JLAB Holidays ReBaseline | MECH TECH; ELEC TECH; PROCUREMENT<$50K 60 NO ESCALATION FY14 | 51,498 | 24272180 | ELOUADRHIRI L | 1 | 1 | LATIFA E | 4211 | 12-024 | 13-002F | EJ | 13-015 | PR |  |  |  |  |  |  |  |  |  |  |  |  |  |  |  |  |  |  |  |  |  |  |  |  |  |  |  |  |  |  |  |  |  |
| 242711.4005a |  | Solder condutor for Prototype Coil Labor FY13 |  | 20d | 2013-09-03 | 2013-09-30 | 24271740 FS-60d | 58d | 0d |  | 8/5 M-F w/JLAB Holidays ReBaseline | MECH TECH [17.78 h]; ELEC TECH [17.78 h] | 1,625.09 | 24272180 | ELOUADRHIRI L | 1 | 1 | LATIFA E | 4211 | 12-024 | 13-002F | EJ | 13-015 | PR |  |  |  |  |  |  |  |  |  |  |  |  |  |  |  |  |  |  |  |  |  |  |  |  |  |  |  |  |  |  |  |  |  |
| 242711.4005b |  | Solder condutor for Prototype Coil Labor FY14 |  | 25d | 2013-10-01 | 2013-11-04 | 242711.4005a, 24271740 FS-60d | 58d | 0d |  | 8/5 M-F w/JLAB Holidays ReBaseline | MECH TECH [22.23 h]; ELEC TECH [22.23 h] | 2,096.04 | 24272180 | ELOUADRHIRI L | 1 | 1 | LATIFA E | 4211 | 12-024 | 13-002F | EJ | 13-015 | PR | 14-001 |  |  |  |  |  |  |  |  |  |  |  |  |  |  |  |  |  |  |  |  |  |  |  |  |  |  |  |  |  |  |  |  |
| 242711.4010 |  | Solder condutor for Coil #7 |  | 57d | 2013-11-05 | 2014-02-06 | 242711.4005b, 242711.4005, 242711.4005a | 77d | 5d |  | 8/5 M-F w/JLAB Holidays ReBaseline | PROCUREMENT<$50K 60; ELEC TECH [40 h]; SCIENTIST [40 h] | 58,027.59 | 24272180 | ELOUADRHIRI L | 1 | 1 | LATIFA E | 4211 | 12-024 | 13-002F | EJ | 13-015 | PR | 14-001 |  |  |  |  |  |  |  |  |  |  |  |  |  |  |  |  |  |  |  |  |  |  |  |  |  |  |  |  |  |  |  |  |
|  | 5 | **1.4.2.7.11.5 SECLAY COIL COLD TESTING FOR TORUS RISK MITIGATION** |  |  | 2013-09-03 | 2015-04-09 |  |  |  |  |  |  |  |  |  |  |  |  |  |  |  |  |  |  |  |  |  |  |  |  |  |  |  |  |  |  |  |  |  |  |  |  |  |  |  |  |  |  |  |  |  |  |  |  |  |  |  |
| 242711.5000 |  | Saclay Cold Tests - Contract Preperation |  | 9d | 2013-09-03 | 2013-09-13 | 9-130M FS+228d | 229d | 0d |  | 8/5 M-F w/JLAB Holidays ReBaseline | SR STAFF [80 h] | 9,328 | 24271985 | ELOUADRHIRI L | 1 | 1 | LATIFA E | 4211 | 12-024 | 13-002F | EJ | 13-015 | PR |  | H |  |  |  |  |  |  |  |  |  |  |  |  |  |  |  |  |  |  |  |  |  |  |  |  |  |  |  |  |  |  |  |
| 242711.5010 |  | Saclay Cold Tests - Oversight Expenses and Labor FY13 |  | 20d | 2013-09-03 | 2013-09-30 | 242711.5000 FS-9d | 229d | 0d |  | 8/5 M-F w/JLAB Holidays ReBaseline | SR STAFF [18.71 h]; TRAVEL | 3,935.98 | 24271985 | ELOUADRHIRI L | 1 | 1 | LATIFA E | 4211 | 12-024 | 13-002F | EJ | 13-015 | PR |  | E |  |  |  |  |  |  |  |  |  |  |  |  |  |  |  |  |  |  |  |  |  |  |  |  |  |  |  |  |  |  |  |
| 242711.5010a |  | Saclay Cold Tests - Oversight Expenses and Labor FY14 |  | 247d | 2013-10-01 | 2014-09-30 | 242711.5000 FS-9d, 242711.5010 | 229d | 0d |  | 8/5 M-F w/JLAB Holidays ReBaseline | SR STAFF [231.11 h]; TRAVEL | 50,165.02 | 24271985 | ELOUADRHIRI L | 1 | 1 | LATIFA E | 4211 | 12-024 | 13-002F | EJ | 13-015 | PR | 14-001 | E |  |  |  |  |  |  |  |  |  |  |  |  |  |  |  |  |  |  |  |  |  |  |  |  |  |  |  |  |  |  |  |
| 242711.5005 |  | Saclay Cold Tests - Kickoff Meeting |  | 19d | 2013-11-01 | 2013-11-27 | 9-140M FS+23d | 346d | 0d |  | 8/5 M-F w/JLAB Holidays ReBaseline | SR STAFF [80 h]; TRAVEL | 19,944.6 | 24271985 | ELOUADRHIRI L | 1 | 1 | LATIFA E | 4211 | 12-024 | 13-002F | EJ | 13-015 | PR | 14-001 | S |  |  |  |  |  |  |  |  |  |  |  |  |  |  |  |  |  |  |  |  |  |  |  |  |  |  |  |  |  |  |  |
| 242711.5015 |  | Saclay Cold Tests - Facility Set-up Phase #1 |  | 118d | 2013-11-01 | 2014-04-30 | 242711.5005 FS-19d, 242711.5000 FS-9d | 346d | 0d |  | 8/5 M-F w/JLAB Holidays ReBaseline | PROCUREMENT<$50K 60; PROCUREMENT>$50K 69 | 103,190 | 24271985 | ELOUADRHIRI L | 1 | 1 | LATIFA E | 4211 | 12-024 | 13-002F | EJ | 13-015 | PR | 14-001 | D |  |  |  |  |  |  |  |  |  |  |  |  |  |  |  |  |  |  |  |  |  |  |  |  |  |  |  |  |  |  |  |
| 242711.5020 |  | Saclay Cold Tests - Facility Set-up Phase #2 |  | 118d | 2013-11-01 | 2014-04-30 | 242711.5005 FS-19d, 242711.5015 FS-118d | 346d | 0d |  | 8/5 M-F w/JLAB Holidays ReBaseline | PROCUREMENT>$50K 69; PROCUREMENT<$50K 60 | 338,463.2 | 24271985 | ELOUADRHIRI L | 1 | 1 | LATIFA E | 4211 | 12-024 | 13-002F | EJ | 13-015 | PR | 14-001 | D |  |  |  |  |  |  |  |  |  |  |  |  |  |  |  |  |  |  |  |  |  |  |  |  |  |  |  |  |  |  |  |
| 242711.5025 |  | Saclay Cold Tests - Cryogenic Tests of Prototype Coil |  | 85d | 2014-04-02 | 2014-07-31 | 242711.3030, 242711.5020 FS-21d | 346d | 343d |  | 8/5 M-F w/JLAB Holidays ReBaseline | PROCUREMENT>$50K 69 | 134,147 | 24271985 | ELOUADRHIRI L | 1 | 1 | LATIFA E | 4211 | 12-024 | 13-002F | EJ | 13-015 | PR | 14-001 | D |  |  |  |  |  |  |  |  |  |  |  |  |  |  |  |  |  |  |  |  |  |  |  |  |  |  |  |  |  |  |  |
| 242711.5010b |  | Saclay Cold Tests - Oversight Expenses and Labor FY15 |  | 75d | 2014-10-01 | 2015-01-28 | 242711.5000 FS-9d, 242711.5010a | 229d | 226d |  | 8/5 M-F w/JLAB Holidays ReBaseline | SR STAFF [70.18 h]; TRAVEL | 15,232.88 | 24271985 | ELOUADRHIRI L | 1 | 1 | LATIFA E | 4211 | 12-024 | 13-002F | EJ | 13-015 | PR | 14-001 | E |  |  |  |  |  |  |  |  |  |  |  |  |  |  |  |  |  |  |  |  |  |  |  |  |  |  |  |  |  |  |  |
| 242711.5030 |  | Saclay Cold Tests - Cryogenic Tests of Coil #7 |  | 85d | 2014-12-01 | 2015-04-09 | 242711.3065 | 72d | 0d |  | 8/5 M-F w/JLAB Holidays ReBaseline | PROCUREMENT>$50K 69 | 134,147 | 24271985 | ELOUADRHIRI L | 1 | 1 | LATIFA E | 4211 | 12-024 | 13-002F | EJ | 13-015 | PR | 14-001 | D |  |  |  |  |  |  |  |  |  |  |  |  |  |  |  |  |  |  |  |  |  |  |  |  |  |  |  |  |  |  |  |
|  | 3 | **1.4.3 CONSTRUCTION HALL C** |  |  | 2009-01-02 | 2016-02-03 |  |  |  |  |  |  |  |  |  |  |  |  |  |  |  |  |  |  |  |  |  |  |  |  |  |  |  |  |  |  |  |  |  |  |  |  |  |  |  |  |  |  |  |  |  |  |  |  |  |  |  |
|  | 1 | **1.4.3.1 MAGNET** |  |  | 2009-01-02 | 2016-02-03 |  |  |  |  |  |  |  |  |  |  |  |  |  |  |  |  |  |  |  |  |  |  |  |  |  |  |  |  |  |  |  |  |  |  |  |  |  |  |  |  |  |  |  |  |  |  |  |  |  |  |  |
|  | 1 | **1.4.3.1.1 HB MAGNET** |  |  | 2009-10-14 | 2015-01-05 |  |  |  |  |  |  |  |  |  |  |  |  |  |  |  |  |  |  |  |  |  |  |  |  |  |  |  |  |  |  |  |  |  |  |  |  |  |  |  |  |  |  |  |  |  |  |  |  |  |  |  |
| 14311000M |  | HB- Award Contract for HB Mag | milestone | 0d | 2009-10-14 | 2009-10-14 | 9-100M | 0d |  | mandatory start 2009-10-14 |  |  |  |  | FENKER H | 1 | 1 | HOWARD F |  |  |  |  |  |  |  |  | 4 | 08-048 | 08-057 | 09-022 |  |  |  |  |  |  |  |  |  |  |  |  |  |  |  |  |  |  |  |  |  |  |  |  |  |  |  |
| 14311002 |  | HB- Contractor Expenses (FROZEN by CR10-063) |  | 20d | 2009-10-14 | 2009-11-10 | 14311000M | 195d | 110d |  |  | PROCUREMENT<$50K 60 | 18,679.35 |  | FENKER H | 1 | 1 | HOWARD F | 4311 |  |  |  |  |  |  |  |  | 08-048 | 08-057 | 09-022 | 07-034 | 10-063 | 10-069 | 10-074 | 11-017 | 11-026 | 11-046 | 12-012 |  |  |  |  |  |  |  |  |  |  |  |  |  |  |  |  |  |  |  |
| 14311005 |  | HB- Finalise Dsgn for HB Mag (FROZEN by CR10-063) |  | 130d | 2009-10-14 | 2010-04-27 | 14311000M | 85d | 0d |  |  | PROCUREMENT<$50K 60; TRAVEL; PROCUREMENT>$50K 69 | 96,833.39 |  | FENKER H | 1 | 1 | HOWARD F | 4311 |  |  |  |  |  |  |  |  | 08-048 | 08-057 | 09-022 |  | 10-063 | 10-069 | 10-074 | 11-017 | 11-026 | 11-046 | 12-012 | APP | 08-016 | 08-042 | 09-012 |  |  |  |  |  |  |  |  |  |  |  |  |  |  |  |
| 143118P1LOE |  | HB Contract Mngmnt for HB Mag |  | 239d | 2009-10-14 | 2010-09-30 | 14311000M | 20d | 0d |  |  | MECH ENG [400 h]; TRAVEL; MECH DES [240 h] | 41,592.74 |  | FENKER H | 1 | 1 | HOWARD F |  |  |  |  |  |  |  |  |  | 08-048 | 08-057 | 09-022 |  |  | 10-069 |  |  | 11-026 |  | 12-012 |  |  |  | 09-012 | 12-036F |  |  |  |  |  |  |  |  |  |  |  |  |  |  |
| 14311010 |  | HB- Dsgn Review of HB Mag (FROZEN by CR10-063) |  | 5d | 2010-04-28 | 2010-05-04 | 14311005, 14311002 | 85d | 0d |  |  | TRAVEL; MECH ENG [40 h] | 4,831.58 |  | FENKER H | 1 | 1 | HOWARD F |  |  |  |  |  |  |  |  |  | 08-048 | 08-057 | 09-022 |  | 10-063 | 10-069 | 10-074 | 11-017 | 11-026 | 11-046 | 12-012 |  |  |  | 09-012 |  |  |  |  |  |  |  |  |  |  |  |  |  |  |  |
| 14311015 |  | HB- Insulate Superconductor (FROZEN by CR10-063) |  | 20d | 2010-05-05 | 2010-06-02 | 14311010 | 85d | 21d |  |  | PROCUREMENT<$50K 60 | 13,185.42 |  | FENKER H | 1 | 1 | HOWARD F | 4311 |  |  |  |  |  |  |  |  | 08-048 | 08-057 | 09-022 |  | 10-063 | 10-069 | 10-074 | 11-017 | 11-026 | 11-046 | 12-012 | APP |  |  |  |  |  |  |  |  |  |  |  |  |  |  |  |  |  |  |
| 14311080 |  | Reverse Entry - Change Request 10-063 |  | 1d | 2010-07-01 | 2010-07-01 | 14311000M FS+175d | 65d | 1d |  |  | PROCUREMENT<$50K 60; MECH ENG [-40 h]; TRAVEL; PROCUREMENT>$50K 69 | -133,529.74 |  | FENKER H | 1 | 1 | HOWARD F |  |  |  |  |  |  |  |  |  |  |  |  |  | 10-063 | 10-069 | 10-074 | 11-017 | 11-026 | 11-046 | 12-012 |  |  |  |  |  |  |  |  |  |  |  |  |  |  |  |  |  |  |  |
| 14311082 |  | Vend Fab HB Magnet Peg Point #1 Preliminary Design Review |  | 84d | 2010-07-02 | 2010-10-29 | 14311080 FS-1d, 14311000M FS+176d | 64d | 0d |  |  | PROCUREMENT<$50K 60 NO ESCALATION | 13,521 |  | FENKER H | 1 | 1 | HOWARD F |  |  |  |  |  |  |  |  |  |  |  |  |  | 10-063 | 10-069 | 10-074 | 11-017 | 11-026 | 11-046 | 12-012 |  |  |  |  |  |  |  |  |  |  |  |  |  |  |  |  |  |  |  |
| 14311082a |  | Vend Fab HB Magnet Peg Point #2 HB Analysis Complete |  | 160d | 2010-07-02 | 2011-02-28 | 14311082 FS-84d | 64d | 0d |  |  | PROCUREMENT>$50K 69 NO ESCALATION; PROCUREMENT<$50K 60 NO ESCALATION | 146,795 |  | FENKER H | 1 | 1 | HOWARD F | 4311 |  |  |  |  |  |  |  |  |  |  |  |  | 10-063 | 10-069 | 10-074 | 11-017 | 11-026 | 11-046 | 12-012 | APP |  |  |  |  |  |  |  |  |  |  |  |  |  |  |  |  |  |  |
| 14311082b |  | Vend Fab HB Magnet Peg Point #3 Intermediate Design Review |  | 247d | 2010-07-02 | 2011-06-30 | 14311082a FS-160d | 64d | 0d |  |  | PROCUREMENT>$50K 69 NO ESCALATION | 175,768 |  | FENKER H | 1 | 1 | HOWARD F |  |  |  |  |  |  |  |  |  |  |  |  |  | 10-063 | 10-069 | 10-074 | 11-017 | 11-026 | 11-046 | 12-012 |  |  |  |  |  |  |  |  |  |  |  |  |  |  |  |  |  |  |  |
| 14311084 |  | Vend Fab HB Magnet Peg Point #4 Final Design Review |  | 332d | 2010-07-02 | 2011-10-31 | 14311015, 14311082b FS-247d | 64d | 0d |  |  | PROCUREMENT>$50K 69 NO ESCALATION | 169,973 |  | FENKER H | 1 | 1 | HOWARD F |  |  |  |  |  |  |  |  |  |  |  |  |  | 10-063 | 10-069 | 10-074 | 11-017 | 11-026 | 11-046 | 12-012 |  |  |  |  |  |  |  |  |  |  |  |  |  |  |  |  |  |  |  |
| 14311086 |  | Vend Fab HB Magnet Peg Point #5a HB Cold Mass Complete |  | 409d | 2010-07-02 | 2012-02-29 | 14311073a FS-332d, 14311084 FS-332d | 64d | 0d |  |  | PROCUREMENT>$50K 69 NO ESCALATION | 81,838 |  | FENKER H | 1 | 1 | HOWARD F |  |  |  |  |  |  |  |  |  |  |  |  |  | 10-063 | 10-069 | 10-074 | 11-017 | 11-026 | 11-046 | 12-012 |  |  |  |  |  |  |  |  |  |  |  |  |  |  |  |  |  |  |  |
| 143118P2LOE |  | HB Contract Mngmnt for HB Mag |  | 248d | 2010-10-01 | 2011-09-30 | 143118P1LOE | 20d | 0d |  |  | MECH DES [80 h]; MECH ENG [400 h]; TRAVEL | 35,449.74 |  | FENKER H | 1 | 1 | HOWARD F |  |  |  |  |  |  |  |  |  | 08-048 |  | 09-022 |  |  | 10-069 |  |  | 11-026 |  | 12-012 |  |  |  |  | 12-036F |  |  |  |  |  |  |  |  |  |  |  |  |  |  |
| 14311073 |  | HB Design Reviews FY11 |  | 104d | 2011-05-05 | 2011-09-30 | 14311082b FS-40d | 64d | 0d |  |  | MECH ENG [33.28 h]; TRAVEL | 4,148.09 |  | FENKER H | 1 | 1 | HOWARD F | 4311 |  |  |  |  |  |  |  |  |  |  |  |  |  |  | 10-074 | 11-017 | 11-026 | 11-046 | 12-012 | APP |  |  |  |  | 12-001 |  |  |  |  |  |  |  |  |  |  |  |  |  |
| 14311086a |  | Vend Fab HB Magnet Peg Point #5b HB Cold Mass Complete |  | 162d | 2011-07-01 | 2012-02-29 | 9-110M FS+184d, 14311086 FS-163d | 64d | 0d |  |  | PROCUREMENT<$50K 60 NO ESCALATION | 34,053 |  | FENKER H | 1 | 1 | HOWARD F |  |  |  |  |  |  |  |  |  |  |  |  |  |  |  | 10-074 | 11-017 | 11-026 | 11-046 | 12-012 |  |  |  |  |  |  |  |  |  |  |  |  |  |  |  |  |  |  |  |
| 14311086b |  | Vend Fab HB Magnet Peg Point #6 Cryostat and Materials Certifications Complete |  | 247d | 2011-07-01 | 2012-06-29 | 14311086a FS-162d | 64d | 0d |  |  | PROCUREMENT<$50K 60 NO ESCALATION; PROCUREMENT>$50K 69 NO ESCALATION | 90,781 |  | FENKER H | 1 | 1 | HOWARD F |  |  |  |  |  |  |  |  |  |  |  |  |  |  |  | 10-074 | 11-017 | 11-026 | 11-046 | 12-012 |  |  |  |  |  |  |  |  |  |  |  |  |  |  |  |  |  |  |  |
| 14311086c |  | Vend Fab HB Magnet Peg Point #7a HB Magnet Cryostated |  | 334d | 2011-07-01 | 2012-10-31 | 14311086b FS-247d | 64d | 0d |  |  | PROCUREMENT>$50K 69 NO ESCALATION | 64,096.1 |  | FENKER H | 1 | 1 | HOWARD F |  |  |  |  |  |  |  |  |  |  |  |  |  |  |  | 10-074 | 11-017 | 11-026 | 11-046 | 12-012 |  |  |  |  |  |  |  |  |  |  |  |  |  |  |  |  |  |  |  |
| 14311073a |  | HB Design Reviews FY12 |  | 21d | 2011-10-03 | 2011-10-31 | 14311073 | 64d | 0d |  |  | TRAVEL; MECH ENG [6.72 h] | 864.33 |  | FENKER H | 1 | 1 | HOWARD F | 4311 |  |  |  |  |  |  |  |  |  |  |  |  |  |  | 10-074 | 11-017 | 11-026 | 11-046 | 12-012 | APP |  |  |  |  | 12-001 |  |  |  |  |  |  |  |  |  |  |  |  |  |
| 143118P3LOE |  | HB Contract Mngmnt for HB Mag |  | 58d | 2011-10-03 | 2011-12-30 | 143118P2LOE | 20d | 0d |  |  | MECH ENG [93.93 h]; MECH DES [18.79 h]; TRAVEL | 8,590.43 |  | FENKER H | 1 | 1 | HOWARD F |  |  |  |  |  |  |  |  |  | 08-048 |  | 09-022 |  |  | 10-069 |  |  | 11-026 |  | 12-012 |  |  |  |  | 12-036F |  |  |  |  |  |  |  |  |  |  |  |  |  |  |
| 14311072 |  | HB Site Inspections FY12 |  | 189d | 2012-01-03 | 2012-09-28 | 14311086 FS-40d | 64d | 0d |  |  | TRAVEL | 2,371.37 |  | FENKER H | 1 | 1 | HOWARD F | 4311 |  |  |  |  |  |  |  |  |  |  |  |  |  |  | 10-074 |  | 11-026 |  |  | APP |  |  |  |  |  | 12-053 |  |  |  |  |  |  |  |  |  |  |  |  |
| 143118P3LOE5 |  | HB Contract Mngmnt for HB Mag |  | 189d | 2012-01-03 | 2012-09-28 | 143118P3LOE | 20d | 0d |  |  | MECH ENG [320 h]; MECH DES [60 h]; TRAVEL | 31,328.6 |  | FENKER H | 1 | 1 | HOWARD F |  |  |  |  |  |  |  |  |  | 08-048 |  | 09-022 |  |  | 10-069 |  |  | 11-026 |  | 12-012 |  |  |  |  | 12-036F |  |  |  |  |  |  |  |  |  |  |  |  |  |  |
| 14311086d |  | Vend Fab HB Magnet Peg Point #7b HB Magnet Cryostated |  | 150d | 2012-04-02 | 2012-10-31 | 14311086c FS-150d, 9-120M FS+120d | 64d | 0d |  |  | PROCUREMENT<$50K 60 NO ESCALATION | 19,923.9 |  | FENKER H | 1 | 1 | HOWARD F |  |  |  |  |  |  |  |  |  |  |  |  |  |  |  | 10-074 | 11-017 | 11-026 | 11-046 | 12-012 |  |  |  |  |  |  |  |  |  |  |  |  |  |  |  |  |  |  |  |
| 14311086f |  | Vend Fab HB Magnet Peg Point #8 Magnet Complete |  | 226d | 2012-04-02 | 2013-02-28 | 14311086d FS-150d | 64d | 0d |  |  | PROCUREMENT<$50K 60 NO ESCALATION; PROCUREMENT>$50K 69 NO ESCALATION | 61,808 |  | FENKER H | 1 | 1 | HOWARD F |  |  |  |  |  |  |  |  |  |  |  |  |  |  |  | 10-074 | 11-017 | 11-026 | 11-046 | 12-012 |  |  |  |  |  |  |  |  |  |  |  |  |  |  |  |  |  |  |  |
| 14311086g |  | Vend Fab HB Magnet Peg Point #9 HB Tested and Mapped at MSU and delivery to JLab |  | 311d | 2012-04-02 | 2013-06-28 | 14311086f FS-226d | 64d |  |  |  | PROCUREMENT>$50K 69 NO ESCALATION | 45,391 |  | FENKER H | 1 | 1 | HOWARD F |  |  |  |  |  |  |  |  |  |  |  |  |  |  |  | 10-074 | 11-017 | 11-026 | 11-046 | 12-012 |  |  |  |  |  |  |  | 11-025 |  |  |  |  |  |  |  |  |  |  |  |
| 14311072a |  | HB Site Inspections FY13 |  | 184d | 2012-10-01 | 2013-06-28 | 14311072 | 64d |  |  |  | TRAVEL | 2,382.3 |  | FENKER H | 1 | 1 | HOWARD F | 4311 |  |  |  |  |  |  |  |  |  |  |  |  |  |  | 10-074 |  | 11-026 |  |  | APP |  |  |  |  |  | 12-053 |  |  |  |  |  |  |  |  |  |  |  |  |
| 143118P4LOE |  | HB Contract Mngmnt for HB Mag |  | 228d | 2012-10-01 | 2013-08-30 | 143118P3LOE5 | 20d |  |  |  | MECH ENG [367.74 h]; MECH DES [73.55 h]; TRAVEL | 37,381 |  | FENKER H | 1 | 1 | HOWARD F |  |  |  |  |  |  |  |  |  | 08-048 |  | 09-022 |  |  | 10-069 |  |  | 11-026 |  | 12-012 |  |  |  |  | 12-036F |  |  |  | 13-014 |  |  |  |  |  |  |  |  |  |  |
| 14311950 |  | Re-Baseline Actuals Adjustment |  | 1d | 2013-08-30 | 2013-08-30 | 9-130M FS+227d | 20d |  |  |  | PROCUREMENT>$50K 69 NO ESCALATION | 370,024.45 |  | FENKER H | 1 | 1 | HOWARD F |  |  |  |  |  |  |  |  |  |  |  |  |  |  |  |  |  |  |  |  |  |  |  |  |  |  |  |  | 13-014 | ADJ |  |  |  |  |  |  |  |  |  |
| 24311072 |  | HB Site Inspections FY13 |  | 20d | 2013-09-03 | 2013-09-30 | 9-130M FS+228d | 368d | 0d |  | 8/5 M-F w/JLAB Holidays ReBaseline | TRAVEL | 1,185.69 | 24311072 | FENKER H | 1 | 1 | HOWARD F | 4311 |  |  | PE | 13-015 | PR |  | U |  |  |  |  |  |  |  | 10-074 |  | 11-026 |  |  | APP |  |  |  |  |  | 12-053 |  |  |  | 13-006F | PE |  |  |  |  |  |  |  |
| 24311110 |  | Vend Fab HB Magnet Peg Point #10 Weld back He Vessel Plate; Shield Preassembly; Fab Vac Wall Parts |  | 43d | 2013-09-03 | 2013-10-31 | 9-130M FS+228d | 49d | 0d |  | 8/5 M-F w/JLAB Holidays ReBaseline | PROCUREMENT>$50K 69 NO ESCALATION | 73,821 | 24311110 | FENKER H | 1 | 1 | HOWARD F |  |  |  |  | 13-015 | PR |  | P |  |  |  |  |  |  |  | 10-074 | 11-017 | 11-026 | 11-046 | 12-012 |  |  |  |  |  |  |  | 11-025 |  |  | 13-006 |  | OPEN OBLIGATION | y | VQ | YES | OB |  |  |
| 24311115 |  | Vend Fab HB Magnet Peg Point #11 Close He Vessel; Preassemble Cryostat Vac Wall |  | 62d | 2013-09-03 | 2013-11-27 | 24311110 FS-43d | 49d | 0d |  | 8/5 M-F w/JLAB Holidays ReBaseline | PROCUREMENT>$50K 69 NO ESCALATION | 37,168 | 24311115 | FENKER H | 1 | 1 | HOWARD F |  |  |  |  | 13-015 | PR |  | P |  |  |  |  |  |  |  | 10-074 |  | 11-026 |  |  |  |  |  |  |  |  |  |  |  |  | 13-006 |  | OPEN OBLIGATION | y | VQ | YES | OB |  |  |
| 24311120 |  | Vend Fab HB Magnet Peg Point #12 NDT & Warm Testing; Assemble Shield to He Vessel |  | 77d | 2013-09-03 | 2013-12-20 | 24311115 FS-62d | 49d | 0d |  | 8/5 M-F w/JLAB Holidays ReBaseline | PROCUREMENT>$50K 69 NO ESCALATION | 83,471 | 24311120 | FENKER H | 1 | 1 | HOWARD F |  |  |  |  | 13-015 | PR |  | P |  |  |  |  |  |  |  | 10-074 |  | 11-026 |  |  |  |  |  |  |  |  |  |  |  |  | 13-006 |  | OPEN OBLIGATION | y | VQ | YES | OB |  |  |
| 24311125 |  | Vend Fab HB Magnet Peg Point #13 Shield Support Assy, Instrumentation & Insulation |  | 77d | 2013-09-03 | 2013-12-20 | 24311120 FS-77d | 49d | 0d |  | 8/5 M-F w/JLAB Holidays ReBaseline | PROCUREMENT>$50K 69 NO ESCALATION | 19,769 | 24311125 | FENKER H | 1 | 1 | HOWARD F |  |  |  |  | 13-015 | PR |  | P |  |  |  |  |  |  |  | 10-074 |  | 11-026 |  |  |  |  |  |  |  |  |  |  |  |  | 13-006 |  | OPEN OBLIGATION | y | VQ | YES | OB |  |  |
| 24311130 |  | Vend Fab HB Magnet Peg Point #14 Suspend He Vessel/Shield; Complete Vac. Walls 2,3 |  | 98d | 2013-09-03 | 2014-01-31 | 24311125 FS-77d | 49d | 0d |  | 8/5 M-F w/JLAB Holidays ReBaseline | PROCUREMENT<$50K 60 NO ESCALATION | 25,966 | 24311130 | FENKER H | 1 | 1 | HOWARD F |  |  |  |  | 13-015 | PR |  | P |  |  |  |  |  |  |  | 10-074 |  | 11-026 |  |  |  |  |  |  |  |  |  |  |  |  | 13-006 |  | OPEN OBLIGATION | y | VQ | YES | OB |  |  |
| 24311135 |  | Vend Fab HB Magnet Peg Point #15 Finish Vac Wall & Support Links |  | 118d | 2013-09-03 | 2014-02-28 | 24311130 FS-98d | 49d | 0d |  | 8/5 M-F w/JLAB Holidays ReBaseline | PROCUREMENT<$50K 60 NO ESCALATION | 22,977 | 24311135 | FENKER H | 1 | 1 | HOWARD F |  |  |  |  | 13-015 | PR |  | P |  |  |  |  |  |  |  | 10-074 |  | 11-026 |  |  |  |  |  |  |  |  |  |  |  |  | 13-006 |  | OPEN OBLIGATION | y | VQ | YES | OB |  |  |
| 24311140 |  | Vend Fab HB Magnet Peg Point #16 Finish & Leak Check Cryo Header |  | 139d | 2013-09-03 | 2014-03-31 | 24311135 FS-118d | 49d | 0d |  | 8/5 M-F w/JLAB Holidays ReBaseline | PROCUREMENT<$50K 60 NO ESCALATION | 15,692 | 24311140 | FENKER H | 1 | 1 | HOWARD F |  |  |  |  | 13-015 | PR |  | P |  |  |  |  |  |  |  | 10-074 |  | 11-026 |  |  |  |  |  |  |  |  |  |  |  |  | 13-006 |  | OPEN OBLIGATION | y | VQ | YES | OB |  |  |
| 24311145 |  | Vend Fab HB Magnet Peg Point #17 Assemble CCR to Magnet |  | 161d | 2013-09-03 | 2014-04-30 | 24311140 FS-139d | 49d | 0d |  | 8/5 M-F w/JLAB Holidays ReBaseline | PROCUREMENT<$50K 60 NO ESCALATION; PROCUREMENT>$50K 69 NO ESCALATION | 26,314.88 | 24311145 | FENKER H | 1 | 1 | HOWARD F |  |  |  |  | 13-015 | PR |  | P |  |  |  |  |  |  |  | 10-074 |  | 11-026 |  |  |  |  |  |  |  |  |  |  |  |  | 13-006 |  | OPEN OBLIGATION | y | VQ | YES | OB |  |  |
| 243118P4LOE |  | HB Contract Mngmnt for HB Mag |  | 20d | 2013-09-03 | 2013-09-30 | 9-130M FS+228d | 683d | 0d |  | 8/5 M-F w/JLAB Holidays ReBaseline | MECH DES [6.45 h]; TRAVEL; MECH ENG [32.25 h] | 3,278.29 | 243118P4LOE | FENKER H | 1 | 1 | HOWARD F |  |  |  | PE | 13-015 | PR |  | E |  | 08-048 |  | 09-022 |  |  | 10-069 |  |  | 11-026 |  | 12-012 |  |  |  |  | 12-036F |  |  |  |  |  | 13-006F | PE | OPEN OBLIGATION |  |  |  |  |  |  |
| 24311072a |  | HB Site Inspections FY14 |  | 183d | 2013-10-01 | 2014-06-30 | 24311072 | 368d |  |  | 8/5 M-F w/JLAB Holidays ReBaseline | TRAVEL | 2,458.3 | 24311072a | FENKER H | 1 | 1 | HOWARD F | 4311 |  |  | PE | 13-015 | PR | 14-001 | U |  |  |  |  |  |  |  | 10-074 |  | 11-026 |  |  | APP |  |  |  |  |  | 12-053 |  |  |  | 13-006F | PE |  |  |  |  |  |  |  |
| 243118P5LOE |  | HB Contract Mngmnt for HB Mag |  | 247d | 2013-10-01 | 2014-09-30 | 243118P4LOE | 683d | 0d |  | 8/5 M-F w/JLAB Holidays ReBaseline | TRAVEL; MECH ENG [280 h]; MECH DES [40 h] | 32,246.7 | 243118P5LOE | FENKER H | 1 | 1 | HOWARD F |  |  |  | PE | 13-015 | PR | 14-001 | E |  | 08-048 |  | 09-022 |  |  | 10-069 |  |  | 11-026 |  | 12-012 |  |  |  |  | 12-036 |  |  |  |  |  | 13-006 | PE |  |  |  |  |  |  |  |
| 24311150 |  | Vend Fab HB Magnet Peg Point #18 Connect Leads, Instr. He Vessel, Leak Check Cryo, Finish Shield Conn. |  | 139d | 2013-11-01 | 2014-05-30 | 24311145 FS-118d | 49d | 0d |  | 8/5 M-F w/JLAB Holidays ReBaseline | PROCUREMENT>$50K 69 NO ESCALATION | 50,515.11 | 24311150 | FENKER H | 1 | 1 | HOWARD F |  |  |  |  | 13-015 | PR |  | P |  |  |  |  |  |  |  | 10-074 |  | 11-026 |  |  |  |  |  |  |  |  |  |  |  |  | 13-006 |  | OPEN OBLIGATION |  | VQ | YES |  |  |  |
| 24311155 |  | Vend Fab HB Magnet Peg Point #19 Finish Insul & Vac; Leak Check; Fab shipping structure |  | 160d | 2013-11-01 | 2014-06-30 | 24311150 FS-139d | 49d | 0d |  | 8/5 M-F w/JLAB Holidays ReBaseline | PROCUREMENT>$50K 69 NO ESCALATION | 33,594 | 24311155 | FENKER H | 1 | 1 | HOWARD F |  |  |  |  | 13-015 | PR |  | P |  |  |  |  |  |  |  | 10-074 |  | 11-026 |  |  |  |  |  |  |  |  |  |  |  |  | 13-006 |  | OPEN OBLIGATION |  | VQ | YES |  |  |  |
| 24311160 |  | Vend Fab HB Magnet Peg Point #20 Crate & Deliver HB Magnet to JLab |  | 182d | 2013-11-01 | 2014-07-31 | 24311155 FS-160d | 49d | 0d |  | 8/5 M-F w/JLAB Holidays ReBaseline | PROCUREMENT>$50K 69 NO ESCALATION | 13,458 | 24311160 | FENKER H | 1 | 1 | HOWARD F |  |  |  |  | 13-015 | PR |  | P |  |  |  |  |  |  |  | 10-074 |  | 11-026 |  |  |  |  |  |  |  |  |  |  |  |  | 13-006 |  | OPEN OBLIGATION |  | VQ | YES |  |  |  |
| 24311165 |  | Vend Fab HB Magnet Peg Point #21 Aceptance, Setup, Testing, and Mapping at JLab |  | 224d | 2013-11-01 | 2014-09-30 | 24311160 FS-182d | 304d | 0d |  | 8/5 M-F w/JLAB Holidays ReBaseline | PROCUREMENT>$50K 69 NO ESCALATION | 35,345 | 24311165 | FENKER H | 1 | 1 | HOWARD F |  |  |  |  | 13-015 | PR |  | P |  |  |  |  |  |  |  | 10-074 |  | 11-026 |  |  |  |  |  |  |  |  |  |  |  |  | 13-006 |  | OPEN OBLIGATION |  | VQ | YES |  |  |  |
| 24311168 |  | Vend Fab HB Magnet Contract Closeout |  | 128d | 2014-04-01 | 2014-09-30 | 24311165 FS-128d | 304d |  |  | 8/5 M-F w/JLAB Holidays ReBaseline | PROCUREMENT>$50K 69 NO ESCALATION | 80,000 | 24311165 | FENKER H | 1 | 1 | HOWARD F |  |  |  |  | 13-015 | PR |  | P |  |  |  |  |  |  |  | 10-074 |  | 11-026 |  |  |  |  |  |  |  |  |  |  |  |  | 13-006 |  | OPEN OBLIGATION |  | VQ | YES |  |  |  |
| 24311170 |  | HB- Factory Mag Test of HB Mag |  | 41d | 2014-05-02 | 2014-06-30 | 24311120 FS+85d | 368d |  |  | 8/5 M-F w/JLAB Holidays ReBaseline | MECH ENG [40 h]; TRAVEL; MECH DES [40 h] | 7,530.5 | 24311170 | FENKER H | 1 | 1 | HOWARD F |  |  |  | PE | 13-015 | PR | 14-001 | H |  |  |  |  |  | 10-063 | 10-069 | 10-074 |  | 11-026 |  |  |  |  |  |  | 12-036 |  |  |  |  |  | 13-006 | PE |  |  |  |  |  |  |  |
| 24311071 |  | HB Drawing Validation |  | 100d | 2014-08-01 | 2014-12-23 | 24311160 | 246d |  |  | 8/5 M-F w/JLAB Holidays ReBaseline | MECH DES [480 h] | 24,624 | 24311071 | FENKER H | 1 | 1 | HOWARD F | 4311 |  |  | PE | 13-015 | PR | 14-001 | S |  | 08-048 |  | 09-022 |  |  | 10-069 | 10-074 |  | 11-026 |  |  | APP | 08-016 |  | 09-012 |  |  |  |  |  |  | 13-006 |  |  |  |  |  |  | Pat |  |
| 24311077 |  | Finducialize Magnet CL of SHMS HB Magnet |  | 1d | 2014-10-01 | 2014-10-01 | 28231000 | 323d | 0d |  | 8/5 M-F w/JLAB Holidays ReBaseline | MECH DES [8 h]; MECH TECH [32 h] | 1,924.64 | 24311077 | FENKER H | 1 | 1 | HOWARD F |  |  |  | EJ | 13-015 | PR | 14-001 | H |  | 08-048 |  | 09-022 |  | 10-063 | 10-069 | 10-074 | 11-017 | 11-026 | 11-046 | 12-012 |  |  |  | 09-012 | 12-036 |  |  |  |  |  | 13-006 |  |  |  |  |  |  |  | 12-054 |
| 243118P6LOE |  | HB Contract Mngmnt for HB Mag |  | 59d | 2014-10-01 | 2015-01-05 | 243118P5LOE | 683d | 745d |  | 8/5 M-F w/JLAB Holidays ReBaseline | TRAVEL; MECH ENG [120 h] | 11,540.15 | 243118P6LOE | FENKER H | 1 | 1 | HOWARD F |  |  |  | PE | 13-015 | PR | 14-001 | E |  | 08-048 |  | 09-022 |  |  | 10-069 |  |  | 11-026 |  | 12-012 |  |  |  |  | 12-036 |  |  |  |  |  | 13-006 | PE |  |  |  |  |  |  |  |

| ID | WBS | Activity | Type | Duration | Start | Finish | Predecessors | Total float | Free float | Constraint | Calendar | Resources | Cost | RESP - Responsibility | STRT%COMP for CM EVM | FNSH%COMP for CM EVM | CAM RESPONSIBLE | CR 08-058 | CR 12-012 | Milestone Level | CR 08-048 | CR 09-022 | CR 09-041 | CR 07-034 | 12 GEV MAJOR PROCUREMENT CATAGORY | Advance Purchase Plan > 500K | CR 08-016 | CR 09-012 | CR 10-067 | CR 10-069 | CR 11-026 | CR 13-006 | CR 11-046 | CR 12-003 | CR 10-001 | Schedule Contingency | CR 10-063 | CR 12-036 | CR 13-014 | ReBaseline Actuals Adjustment | BOE NOTES | Original Activity ID Rebaseline | Over Under Fixed | EVMS Reporting Codes | BOE Procurement | BOE Adder | CR 13-015 | Post Rebaseline | Obligated Prior to Rebaseline | CR 12-054 | BOE Labor | BOE Expenses | CR 14-001 | Pat's Code |
| --- | --- | --- | --- | --- | --- | --- | --- | --- | --- | --- | --- | --- | --- | --- | --- | --- | --- | --- | --- | --- | --- | --- | --- | --- | --- | --- | --- | --- | --- | --- | --- | --- | --- | --- | --- | --- | --- | --- | --- | --- | --- | --- | --- | --- | --- | --- | --- | --- | --- | --- | --- | --- | --- | --- |
|  | 2 | **1.4.3.1.2 Q-1 QUADRUPOLE** |  |  | 2009-01-02 | 2015-12-22 |  |  |  |  |  |  |  |  |  |  |  |  |  |  |  |  |  |  |  |  |  |  |  |  |  |  |  |  |  |  |  |  |  |  |  |  |  |  |  |  |  |  |  |  |  |  |  |  |
| 14312909LOE |  | Q1- FY09 Proj Mngmnt H-C upgrade |  | 189d | 2009-01-02 | 2009-09-30 | 14312909LOEX | 20d | 0d |  |  | SCIENTIST [337.15 h] | 21,665.26 | FENKER H | 1 | 1 | HOWARD F | 08-058 | 12-012 |  |  |  |  |  |  |  |  |  |  |  |  |  |  |  |  |  |  |  |  |  |  |  |  |  |  |  |  |  |  |  |  |  |  |  |
| 14312000M |  | Q1- Award Contract for Q1 | milestone | 0d | 2009-03-16 | 2009-03-16 | 9-090M, 122311056 | 0d |  | mandatory start 2009-03-16 |  |  |  | FENKER H | 1 | 1 | HOWARD F |  |  | 4 | 08-048 | 09-022 | 09-041 |  |  |  |  |  |  |  |  |  |  |  |  |  |  |  |  |  |  |  |  |  |  |  |  |  |  |  |  |  |  |  |
| 14312002 |  | Q1- Contractor Expenses (Frozen and Reversed by Activity 14312011 per CR 09-041) |  | 20d | 2009-03-16 | 2009-04-10 | 9-090M FS+108d | 120d |  |  |  | PROCUREMENT>$50K 69 | 20,231.53 | FENKER H | 1 | 1 | HOWARD F |  |  |  | 08-048 |  | 09-041 | 07-034 | 4312 |  |  |  |  |  |  |  |  |  |  |  |  |  |  |  |  |  |  |  |  |  |  |  |  |  |  |  |  |  |
| 14312010 |  | Q1- Finalize Dsgn of Q1 First Phase (Frozen and Reversed by Activity 14312011 per CR 09-041) |  | 33.25d | 2009-03-16 | 2009-04-30 | 9-090M FS+108d | 106.75d |  |  |  | TRAVEL | 2,227.93 | FENKER H | 1 | 1 | HOWARD F |  |  |  | 08-048 | 09-022 | 09-041 |  | 4312 | APP | 08-016 | 09-012 |  |  |  |  |  |  |  |  |  |  |  |  |  |  |  |  |  |  |  |  |  |  |  |  |  |  |
| 143128P1LOE |  | Q1- P-1 Contract Mngmnt for Q1 |  | 140d | 2009-03-16 | 2009-09-30 | 14312909LOEX FS+49d | 573d | 0d |  |  | TRAVEL; MECH ENG [108 h]; MECH DES [72 h] | 12,603.52 | FENKER H | 1 | 1 | HOWARD F |  | 12-012 |  | 08-048 | 09-022 |  |  |  |  |  |  | 10-067 | 10-069 | 11-026 | 13-006F |  |  |  |  |  |  |  |  |  |  |  |  |  |  |  |  |  |  |  |  |  |  |
| 14312010a |  | Q1- Finalize Dsgn of Q1 " Final Phase" (Frozen and Reversed by Activity 14312011 per CR 09-041) |  | 32d | 2009-06-17 | 2009-07-31 | 9-090M FS+174d | 42d |  |  |  | TRAVEL | 1,436.89 | FENKER H | 1 | 1 | HOWARD F |  |  |  | 08-048 | 09-022 | 09-041 |  | 4312 | APP | 08-016 | 09-012 |  |  |  |  |  |  |  |  |  |  |  |  |  |  |  |  |  |  |  |  |  |  |  |  |  |  |
| 14312011 |  | Reverse Entry for Activities 14312002, 14312010 and 14312010a per CR 09-041 |  | 1d | 2009-08-03 | 2009-08-03 | 9-090M FS+206d | 41d |  |  |  | TRAVEL; PROCUREMENT>$50K 69 | -23,896.35 | FENKER H | 1 | 1 | HOWARD F |  |  |  |  |  | 09-041 |  | 4312 |  |  |  |  |  |  |  |  |  |  |  |  |  |  |  |  |  |  |  |  |  |  |  |  |  |  |  |  |  |
| 14312015 |  | Vend Fab Q1 Procure Materials |  | 10d | 2009-08-03 | 2009-08-14 | 9-090M FS+206d | 1023d |  |  |  | PROCUREMENT>$50K 69; PROCUREMENT<$50K 60 | 108,588.4 | FENKER H | 1 | 1 | HOWARD F |  | 12-012 |  | 08-048 | 09-022 | 09-041 |  | 4312 |  |  | 09-012 |  | 10-069 | 11-026 |  | 11-046 | 12-003 |  |  |  |  |  |  |  |  |  |  |  |  |  |  |  |  |  |  |  |  |
| 14312020 |  | Vend Fab Q1 Completion of Magnetic and Stress Analysis |  | 130d | 2009-08-03 | 2010-02-12 | 9-090M FS+206d | 903d |  |  |  | PROCUREMENT>$50K 69 NO ESCALATION | 54,294.2 | FENKER H | 1 | 1 | HOWARD F |  | 12-012 |  | 08-048 | 09-022 | 09-041 |  | 4312 | APP |  | 09-012 |  | 10-069 | 11-026 |  | 11-046 | 12-003 | 10-001A |  |  |  |  |  |  |  |  |  |  |  |  |  |  |  |  |  |  |  |
| 14312025 |  | Vend Fab Q1 Completion of Trial Wind |  | 150d | 2009-08-03 | 2010-03-15 | 9-090M FS+206d | 883d |  |  |  | PROCUREMENT>$50K 69 NO ESCALATION | 54,294.2 | FENKER H | 1 | 1 | HOWARD F |  | 12-012 |  | 08-048 | 09-022 | 09-041 |  | 4312 | APP | 08-016 | 09-012 |  | 10-069 | 11-026 |  | 11-046 | 12-003 | 10-001A |  |  |  |  |  |  |  |  |  |  |  |  |  |  |  |  |  |  |  |
| 14312032 |  | Vend Fab Q1 Completion of Preliminary Design Review |  | 235d | 2009-08-03 | 2010-07-14 | 9-090M FS+206d | 798d |  |  |  | PROCUREMENT>$50K 69 NO ESCALATION | 108,588.4 | FENKER H | 1 | 1 | HOWARD F |  | 12-012 |  | 08-048 | 09-022 | 09-041 |  | 4312 | APP |  | 09-012 |  | 10-069 | 11-026 |  | 11-046 | 12-003 | 10-001A |  |  |  |  |  |  |  |  |  |  |  |  |  |  |  |  |  |  |  |
| 14312036 |  | Vend Fab Q1 Completion of Cold Mass Components (Frozen Per CR12-003) |  | 431d | 2009-08-03 | 2011-04-29 | 9-090M FS+206d | 602d |  |  |  | PROCUREMENT>$50K 69 NO ESCALATION | 54,294.2 | FENKER H | 1 | 1 | HOWARD F |  | 12-012 |  | 08-048 | 09-022 | 09-041 |  | 4312 | APP | 08-016 | 09-012 | 10-067 | 10-069 | 11-026 |  | 11-046 | 12-003 | 10-001A | SC |  |  |  |  |  |  |  |  |  |  |  |  |  |  |  |  |  |  |
| 14312040 |  | Vend Fab Q1 Completion of Cold Mass Assembly (Frozen Per CR12-003) |  | 494d | 2009-08-03 | 2011-07-29 | 9-090M FS+206d | 500d | 0d |  |  | PROCUREMENT>$50K 69 NO ESCALATION | 108,588.4 | FENKER H | 1 | 1 | HOWARD F |  | 12-012 |  | 08-048 | 09-022 | 09-041 |  | 4312 | APP | 08-016 | 09-012 | 10-067 | 10-069 | 11-026 |  | 11-046 | 12-003 | 10-001A | SC |  |  |  |  |  |  |  |  |  |  |  |  |  |  |  |  |  |  |
| 14312041 |  | Vend Fab Q1 Warm Testing Complete (Frozen Per CR12-003) |  | 517d | 2009-08-03 | 2011-08-31 | 9-090M FS+206d | 511d | 0d |  |  | PROCUREMENT>$50K 69 NO ESCALATION | 108,588.4 | FENKER H | 1 | 1 | HOWARD F |  | 12-012 |  |  |  |  |  | 4312 | APP |  |  | 10-067 | 10-069 | 11-026 |  | 11-046 | 12-003 |  | SC |  |  |  |  |  |  |  |  |  |  |  |  |  |  |  |  |  |  |
| 14312042 |  | Vend Fab Q1 Completion of Final Design Review |  | 410d | 2009-08-03 | 2011-03-31 | 9-090M FS+206d | 623d |  |  |  | PROCUREMENT>$50K 69 NO ESCALATION | 54,294.2 | FENKER H | 1 | 1 | HOWARD F |  | 12-012 |  | 08-048 | 09-022 | 09-041 |  |  |  |  |  | 10-067 | 10-069 | 11-026 |  | 11-046 | 12-003 | 10-001A | SC |  |  |  |  |  |  |  |  |  |  |  |  |  |  |  |  |  |  |
| 14312045 |  | Vend Fab Q1 Completion of Cryostat Components (Frozen Per CR12-003) |  | 474d | 2009-08-03 | 2011-06-30 | 9-090M FS+206d | 559d |  |  |  | PROCUREMENT>$50K 69 NO ESCALATION | 108,588.4 | FENKER H | 1 | 1 | HOWARD F |  | 12-012 |  | 08-048 | 09-022 | 09-041 |  | 4312 | APP |  |  | 10-067 | 10-069 | 11-026 |  | 11-046 | 12-003 | 10-001A | SC |  |  |  |  |  |  |  |  |  |  |  |  |  |  |  |  |  |  |
| 14312046 |  | Vend Fab Q1 Completion of Cryostat Assembly |  | 884d | 2009-08-03 | 2013-02-28 | 14315031M FS-658d, 14312045a FS-936d, 9-090M FS+206d | 20d | 0d |  |  | PROCUREMENT>$50K 69 NO ESCALATION | 54,294.2 | FENKER H | 1 | 1 | HOWARD F |  | 12-012 |  |  |  | 09-041 |  |  |  |  |  | 10-067 | 10-069 | 11-026 |  | 11-046 | 12-003 | 10-001A | SC | 10-063 | 12-036F |  |  |  |  |  |  |  |  |  |  |  |  |  |  |  |  |
| 14312047 |  | Vend Fab Q1 Completion of Magnet Assembly |  | 927d | 2009-08-03 | 2013-04-30 | 14312046 FS-884d | 20d | 0d |  |  | PROCUREMENT>$50K 69 NO ESCALATION | 54,294.2 | FENKER H | 1 | 1 | HOWARD F |  | 12-012 |  |  |  | 09-041 |  |  |  |  |  | 10-067 | 10-069 | 11-026 |  | 11-046 | 12-003 | 10-001A | SC |  | 12-036F |  |  |  |  |  |  |  |  |  |  |  |  |  |  |  |  |
| 14312048 |  | Vend Fab Q1 Completion of Factory Tests by Vendor |  | 969d | 2009-08-03 | 2013-06-28 | 14312047 FS-927d, 14315038 FS-743d | 20d | 0d |  |  | PROCUREMENT>$50K 69 NO ESCALATION | 54,294.2 | FENKER H | 1 | 1 | HOWARD F |  | 12-012 |  |  |  | 09-041 |  |  |  |  |  | 10-067 | 10-069 | 11-026 |  | 11-046 | 12-003 | 10-001A | SC | 10-063 | 12-036F |  |  |  |  |  |  |  |  |  |  |  |  |  |  |  |  |
| 14312050 |  | Vend Fab Q1 Magnet System Delivery |  | 991d | 2009-08-03 | 2013-07-31 | 14312048 FS-969d | 20d | 0d |  |  | PROCUREMENT>$50K 69 NO ESCALATION | 54,294.2 | FENKER H | 1 | 1 | HOWARD F |  | 12-012 |  | 08-048 | 09-022 | 09-041 |  |  |  |  | 09-012 | 10-067 | 10-069 | 11-026 |  | 11-046 | 12-003 | 10-001A | SC |  | 12-036F |  |  |  |  |  |  |  |  |  |  |  |  |  |  |  |  |
| 143128P2LOE |  | Q1- P-2 Contract Mngmnt for Q1 |  | 248d | 2009-10-01 | 2010-09-30 | 143128P1LOE | 573d | 0d |  |  | MECH DES [240 h]; TRAVEL; MECH ENG [400 h] | 50,383.02 | FENKER H | 1 | 1 | HOWARD F |  | 12-012 |  | 08-048 |  | 09-041 |  |  |  |  |  | 10-067 | 10-069 | 11-026 | 13-006F |  |  |  |  |  |  |  |  |  |  |  |  |  |  |  |  |  |  |  |  |  |  |
| 14312910LOE |  | Q1- FY10 Proj Mngmnt H-C upgrade |  | 248d | 2009-10-01 | 2010-09-30 | 14312909LOE | 20d | 0d |  |  | SCIENTIST [877.6 h] | 58,193.66 | FENKER H | 1 | 1 | HOWARD F |  | 12-012 |  |  |  |  |  |  |  |  |  |  |  |  |  |  |  |  |  |  |  |  |  |  |  |  |  |  |  |  |  |  |  |  |  |  |  |
| 143128P3LOE |  | Q1- P-3 Contract Mngmnt for Q1 |  | 248d | 2010-10-01 | 2011-09-30 | 143128P2LOE | 573d | 0d |  |  | TRAVEL; MECH DES [80 h]; MECH ENG [360 h] | 37,267.09 | FENKER H | 1 | 1 | HOWARD F |  | 12-012 |  | 08-048 |  |  |  |  |  |  |  | 10-067 | 10-069 | 11-026 | 13-006F |  |  |  |  |  |  |  |  |  |  |  |  |  |  |  |  |  |  |  |  |  |  |
| 14312911LOE |  | Q1- FY11 Proj Mngmnt H-C upgrade |  | 248d | 2010-10-01 | 2011-09-30 | 14312910LOE | 20d | 0d |  |  | SCIENTIST [877.6 h] | 60,054.17 | FENKER H | 1 | 1 | HOWARD F |  | 12-012 |  |  |  |  |  |  |  |  |  |  |  |  |  |  |  |  |  |  |  |  |  |  |  |  |  |  |  |  |  |  |  |  |  |  |  |
| 14312052M |  | Factory Low Current Mag Test of Q1 Complete | milestone | 0d | 2011-08-31 | 2011-08-31 | 14312040, 14312041 | 511d | 11d |  |  |  |  | FENKER H | 1 | 1 | HOWARD F |  | 12-012 |  |  |  | 09-041 |  |  |  |  |  | 10-067 | 10-069 | 11-026 |  | 11-046 | 12-003 |  |  |  |  |  |  |  |  |  |  |  |  |  |  |  |  |  |  |  |  |
| 14312005 |  | Q1- Final Dsgn Review |  | 5d | 2011-09-19 | 2011-09-23 | 14312052M, 14312040 FS+34d | 500d |  |  |  | MECH DES [40 h]; TRAVEL; MECH ENG [40 h] | 9,120.54 | FENKER H | 1 | 1 | HOWARD F |  | 12-012 |  | 08-048 | 09-022 | 09-041 |  |  |  |  |  | 10-067 | 10-069 | 11-026 |  | 11-046 | 12-003 |  |  |  |  |  |  |  |  |  |  |  |  |  |  |  |  |  |  |  |  |
| 143128P4LOE |  | Q1- P-4 Contract Mngmnt for Q1 |  | 247d | 2011-10-03 | 2012-09-28 | 143128P3LOE | 573d | 0d |  |  | MECH ENG [360 h]; MECH DES [80 h]; TRAVEL | 38,456.85 | FENKER H | 1 | 1 | HOWARD F |  | 12-012 |  | 08-048 | 09-022 | 09-041 |  |  |  |  |  | 10-067 | 10-069 | 11-026 | 13-006F |  |  |  |  |  |  |  |  |  |  |  |  |  |  |  |  |  |  |  |  |  |  |
| 14312912LOE |  | Q1- FY12 Proj Mngmnt H-C upgrade |  | 247d | 2011-10-03 | 2012-09-28 | 14312911LOE | 20d | 0d |  |  | SCIENTIST [874 h] | 61,713.14 | FENKER H | 1 | 1 | HOWARD F |  | 12-012 |  |  |  |  |  |  |  |  |  |  |  |  |  |  |  |  |  |  |  |  |  |  |  |  |  |  |  |  |  |  |  |  |  |  |  |
| 14312034 |  | Reverse Entry for activities 14312036,14312040,14312041 and 14312045 per CR12-003) |  | 5d | 2011-11-01 | 2011-11-07 | 9-120M FS+21d | 221d |  |  |  | PROCUREMENT>$50K 69 NO ESCALATION | -380,059.4 | FENKER H | 1 | 1 | HOWARD F |  |  |  | 08-048 | 09-022 | 09-041 |  | 4312 | APP |  | 09-012 |  | 10-069 | 11-026 |  | 11-046 | 12-003 | 10-001A |  |  |  |  |  |  |  |  |  |  |  |  |  |  |  |  |  |  |  |
| 14312038 |  | Vend Fab Q1 Completion of Cold Mass Components (Revised Per CR12-003) |  | 37d | 2011-11-01 | 2011-12-30 | 9-120M FS+21d | 255d | 0d |  |  | PROCUREMENT>$50K 69 NO ESCALATION | 108,588.4 | FENKER H | 1 | 1 | HOWARD F |  | 12-012 |  | 08-048 | 09-022 | 09-041 |  | 4312 | APP | 08-016 | 09-012 | 10-067 | 10-069 | 11-026 |  | 11-046 | 12-003 | 10-001A | SC |  | 12-036F |  |  |  |  |  |  |  |  |  |  |  |  |  |  |  |  |
| 14312040a |  | Vend Fab Q1 Completion of Cold Mass Assembly (Revised Per CR12-003) |  | 142d | 2011-11-01 | 2012-05-31 | 14312038 FS-37d | 255d | 0d |  |  | PROCUREMENT>$50K 69 NO ESCALATION | 54,294.2 | FENKER H | 1 | 1 | HOWARD F |  | 12-012 |  | 08-048 | 09-022 | 09-041 |  | 4312 | APP | 08-016 | 09-012 | 10-067 | 10-069 | 11-026 |  | 11-046 | 12-003 | 10-001A | SC |  | 12-036F |  |  |  |  |  |  |  |  |  |  |  |  |  |  |  |  |
| 14312040d |  | Vend Fab Q1 Completion of Cold Mass Testing |  | 226d | 2011-11-01 | 2012-09-28 | 14312040a FS-142d | 255d | 0d |  |  | PROCUREMENT>$50K 69 NO ESCALATION | 54,294.2 | FENKER H | 1 | 1 | HOWARD F |  | 12-012 |  | 08-048 | 09-022 | 09-041 |  | 4312 | APP | 08-016 | 09-012 | 10-067 | 10-069 | 11-026 |  | 11-046 | 12-003 | 10-001A | SC |  | 12-036F |  |  |  |  |  |  |  |  |  |  |  |  |  |  |  |  |
| 14312041a |  | Vend Fab Q1 Warm Testing Complete (Revised Per CR12-003) |  | 162d | 2011-11-01 | 2012-06-29 | 14312040d FS-226d | 255d | 0d |  |  | PROCUREMENT>$50K 69 NO ESCALATION | 54,294.2 | FENKER H | 1 | 1 | HOWARD F |  | 12-012 |  |  |  |  |  | 4312 | APP |  |  | 10-067 | 10-069 | 11-026 |  | 11-046 | 12-003 |  | SC |  | 12-036F |  |  |  |  |  |  |  |  |  |  |  |  |  |  |  |  |
| 14312045a |  | Vend Fab Q1 Completion of Cryostat Components (Revised Per CR12-003) |  | 142d | 2011-11-01 | 2012-05-31 | 14312041a FS-162d | 255d | 235d |  |  | PROCUREMENT>$50K 69 NO ESCALATION | 108,588.4 | FENKER H | 1 | 1 | HOWARD F |  | 12-012 |  | 08-048 | 09-022 | 09-041 |  | 4312 | APP |  |  | 10-067 | 10-069 | 11-026 |  | 11-046 | 12-003 | 10-001A | SC |  | 12-036F |  |  |  |  |  |  |  |  |  |  |  |  |  |  |  |  |
| 14312050c |  | Vend Fab Q1 Magnet Acceptance |  | 422d | 2011-12-19 | 2013-08-30 | 14312050 FS-400d | 20d |  |  |  | PROCUREMENT>$50K 69 NO ESCALATION | 66,540.62 | FENKER H | 1 | 1 | HOWARD F |  | 12-012 |  |  |  |  |  |  |  |  |  | 10-067 | 10-069 | 11-026 |  | 11-046 | 12-003 |  |  |  | 12-036 | 13-014 |  |  |  |  |  |  |  |  |  |  |  |  |  |  |  |
| 143128P5LOE |  | Q1- P-5 Contract Mngmnt for Q1 |  | 228d | 2012-10-01 | 2013-08-30 | 143128P4LOE | 573d | 0d |  |  | MECH ENG [330.97 h]; TRAVEL; MECH DES [73.55 h] | 38,989.37 | FENKER H | 1 | 1 | HOWARD F |  | 12-012 |  | 08-048 | 09-022 | 09-041 |  |  |  |  |  | 10-067 | 10-069 | 11-026 | 13-006F |  |  |  |  |  |  | 13-014 |  |  |  |  |  |  |  |  |  |  |  |  |  |  |  |
| 14312913LOE |  | Q1- FY13 Proj Mngmnt H-C upgrade |  | 228d | 2012-10-01 | 2013-08-30 | 14312912LOE | 20d |  |  |  | SCIENTIST [809.03 h] | 58,945.93 | FENKER H | 1 | 1 | HOWARD F |  | 12-012 |  |  |  |  |  |  |  |  |  |  | 10-069 |  |  |  |  |  |  |  |  | 13-014 |  |  |  |  |  |  |  |  |  |  |  |  |  |  |  |
| 143128P5TLOE |  | Q1- P-5 Extra Travel for Q1 Contract Mgmt |  | 169d | 2013-01-02 | 2013-08-30 | 143128P5LOE FS-169d | 573d |  |  |  | TRAVEL | 5,901.59 | FENKER H | 1 | 1 | HOWARD F |  |  |  |  |  |  |  |  |  |  |  |  |  |  | 13-006 |  |  |  |  |  |  | 13-014 |  |  |  |  |  |  |  |  |  |  |  |  |  |  |  |
| 143128PC13LOE |  | Q1- Contract Oversight Consultant FY13 |  | 169d | 2013-01-02 | 2013-08-30 | 9-130M FS+59d | 573d |  |  |  | PLABOR | 8,047.62 | FENKER H | 1 | 1 | HOWARD F |  |  |  |  |  |  |  |  |  |  |  |  |  |  | 13-006 |  |  |  |  |  |  | 13-014 |  |  |  |  |  |  |  |  |  |  |  |  |  |  |  |
| 14312950 |  | Re-Baseline Actuals Adjustment |  | 1d | 2013-08-30 | 2013-08-30 | 9-130M FS+227d | 20d |  |  |  | PROCUREMENT>$50K 69 NO ESCALATION | -220,221.78 | FENKER H | 1 | 1 | HOWARD F |  |  |  |  |  |  |  |  |  |  |  |  |  |  |  |  |  |  |  |  |  | 13-014 | ADJ |  |  |  |  |  |  |  |  |  |  |  |  |  |  |
| 24312040d |  | Vend Fab Q1 Completion of Cold Mass Testing |  | 98d | 2013-09-03 | 2014-01-31 | 9-130M FS+228d | 472d | 0d |  | 8/5 M-F w/JLAB Holidays ReBaseline | PROCUREMENT>$50K 69 NO ESCALATION | 54,294.2 | FENKER H | 1 | 1 | HOWARD F |  | 12-012 |  | 08-048 | 09-022 | 09-041 |  | 4312 | APP | 08-016 | 09-012 | 10-067 | 10-069 | 11-026 | 13-006F | 11-046 | 12-003 | 10-001A | SC |  | 12-036F |  |  | OPEN OBLIGATION | 24312040d | y | P | OB | YES | 13-015 | PR | OB |  |  |  |  |  |
| 24312041a |  | Vend Fab Q1 Warm Testing Complete |  | 98d | 2013-09-03 | 2014-01-31 | 24312040d FS-98d | 472d | 105d |  | 8/5 M-F w/JLAB Holidays ReBaseline | PROCUREMENT>$50K 69 NO ESCALATION | 54,294.2 | FENKER H | 1 | 1 | HOWARD F |  | 12-012 |  |  |  |  |  | 4312 | APP |  |  | 10-067 | 10-069 | 11-026 | 13-006F | 11-046 | 12-003 |  | SC |  | 12-036F |  |  | OPEN OBLIGATION | 24312041a | y | P | OB | YES | 13-015 | PR | OB |  |  |  |  |  |
| 24312046 |  | Vend Fab Q1 Completion of Cryostat Assembly |  | 161d | 2013-09-03 | 2014-04-30 | 9-130M FS+228d | 87d | 0d |  | 8/5 M-F w/JLAB Holidays ReBaseline | PROCUREMENT>$50K 69 NO ESCALATION | 54,294.2 | FENKER H | 1 | 1 | HOWARD F |  | 12-012 |  |  |  | 09-041 |  |  |  |  |  | 10-067 | 10-069 | 11-026 | 13-006 | 11-046 | 12-003 | 10-001A | SC | 10-063 | 12-036F |  |  | OPEN OBLIGATION | 24312046 | y | P | OB | YES | 13-015 | PR | OB |  |  |  |  |  |
| 24312047 |  | Vend Fab Q1 Completion of Magnet Assembly |  | 182d | 2013-09-03 | 2014-05-30 | 24312046 FS-161d | 87d | 0d |  | 8/5 M-F w/JLAB Holidays ReBaseline | PROCUREMENT>$50K 69 NO ESCALATION | 54,294.2 | FENKER H | 1 | 1 | HOWARD F |  | 12-012 |  |  |  | 09-041 |  |  |  |  |  | 10-067 | 10-069 | 11-026 | 13-006 | 11-046 | 12-003 | 10-001A | SC |  | 12-036F |  |  | OPEN OBLIGATION | 24312047 | y | P | OB | YES | 13-015 | PR | OB |  |  |  |  |  |
| 24312048 |  | Vend Fab Q1 Completion of Factory Tests by Vendor |  | 203d | 2013-09-03 | 2014-06-30 | 24312047 FS-182d | 87d | 0d |  | 8/5 M-F w/JLAB Holidays ReBaseline | PROCUREMENT>$50K 69 NO ESCALATION | 54,294.2 | FENKER H | 1 | 1 | HOWARD F |  | 12-012 |  |  |  | 09-041 |  |  |  |  |  | 10-067 | 10-069 | 11-026 | 13-006 | 11-046 | 12-003 | 10-001A | SC | 10-063 | 12-036F |  |  | OPEN OBLIGATION | 24312048 | y | P | OB |  | 13-015 | PR | OB |  |  |  |  |  |
| 24312050 |  | Vend Fab Q1 Magnet System Delivery |  | 203d | 2013-09-03 | 2014-06-30 | 24312048 FS-203d | 87d | 0d |  | 8/5 M-F w/JLAB Holidays ReBaseline | PROCUREMENT>$50K 69 NO ESCALATION | 54,294.2 | FENKER H | 1 | 1 | HOWARD F |  | 12-012 |  | 08-048 | 09-022 | 09-041 |  |  |  |  | 09-012 | 10-067 | 10-069 | 11-026 | 13-006 | 11-046 | 12-003 | 10-001A | SC |  | 12-036F |  |  | OPEN OBLIGATION | 24312050 | y | P | OB | YES | 13-015 | PR | OB |  |  |  |  |  |
| 24312050c |  | Vend Fab Q1 Magnet Acceptance |  | 246d | 2013-09-03 | 2014-08-29 | 24312050 FS-203d | 271d | 2d |  | 8/5 M-F w/JLAB Holidays ReBaseline | PROCUREMENT>$50K 69 NO ESCALATION | 108,588.4 | FENKER H | 1 | 1 | HOWARD F |  | 12-012 |  |  |  |  |  |  |  |  |  | 10-067 | 10-069 | 11-026 | 13-006 | 11-046 | 12-003 |  |  |  | 12-036 |  |  | OPEN OBLIGATION | 24312050c | y | P | OB | YES | 13-015 | PR | OB |  |  |  |  |  |
| 24312060 |  | Q1 Schedule Acceleration Incentives |  | 203d | 2013-09-03 | 2014-06-30 | 9-130M FS+228d | 367d | 39d |  | 8/5 M-F w/JLAB Holidays ReBaseline | PROCUREMENT<$50K 60 NO ESCALATION FY14 | 45,000 | FENKER H | 1 | 1 | HOWARD F |  | 12-012 |  |  |  |  |  |  |  |  |  | 10-067 | 10-069 | 11-026 | 13-006 |  | 12-003 |  |  |  | 12-036 |  |  |  | 24312060 | y | D | EJ |  | 13-015 | PR | OB | 12-054 |  |  |  |  |
| 243128P5LOE |  | Q1- P-5 Contract Mngmnt for Q1 |  | 20d | 2013-09-03 | 2013-09-30 | 9-130M FS+228d | 249d | 0d |  | 8/5 M-F w/JLAB Holidays ReBaseline | MECH ENG [29.03 h]; TRAVEL; MECH DES [6.45 h] | 3,419.35 | FENKER H | 1 | 1 | HOWARD F |  | 12-012 |  | 08-048 | 09-022 | 09-041 |  |  |  |  |  | 10-067 | 10-069 | 11-026 | 13-006F |  |  |  |  |  |  |  |  | OPEN OBLIGATION | 243128P5LOE |  | E |  |  | 13-015 | PR |  |  | PE | PE |  |  |
| 243128P5TLOE |  | Q1- P-5 Extra Travel for Q1 Contract Mgmt |  | 20d | 2013-09-03 | 2013-09-30 | 243128P5LOE FS-20d | 249d | 0d |  | 8/5 M-F w/JLAB Holidays ReBaseline | TRAVEL | 698.26 | FENKER H | 1 | 1 | HOWARD F |  |  |  |  |  |  |  |  |  |  |  |  |  |  | 13-006 |  |  |  |  |  |  |  |  |  | 243128P5TLOE |  | E |  |  | 13-015 | PR |  |  | PE | PE |  |  |
| 243128PC13LOE |  | Q1- Contract Oversight Consultant |  | 98d | 2013-09-03 | 2014-01-31 | 9-130M FS+228d | 784d | 0d |  | 8/5 M-F w/JLAB Holidays ReBaseline | PROCUREMENT<$50K 60 NO ESCALATION FY14 | 4,000 | FENKER H | 1 | 1 | HOWARD F |  |  |  |  |  |  |  |  |  |  |  |  |  |  | 13-006 |  |  |  |  |  |  |  |  |  | 243128PC13LOE | y | E | OB |  | 13-015 | PR | OB |  |  |  |  |  |
| 24312913LOE |  | Q1- FY13 Proj Mngmnt H-C upgrade |  | 20d | 2013-09-03 | 2013-09-30 | 9-130M FS+228d | 439d | 0d |  | 8/5 M-F w/JLAB Holidays ReBaseline | SCIENTIST [70.95 h] | 5,169.42 | FENKER H | 1 | 1 | HOWARD F |  | 12-012 |  |  |  |  |  |  |  |  |  |  | 10-069 |  | 13-006F |  |  |  |  |  |  |  |  | OPEN OBLIGATION | 24312913LOE |  | E |  |  | 13-015 | PR |  |  | PE |  |  |  |
| 243128P6LOE |  | Q1- P-6 Contract Mngmnt for Q1 |  | 247d | 2013-10-01 | 2014-09-30 | 243128P5TLOE | 249d | 0d |  | 8/5 M-F w/JLAB Holidays ReBaseline | TRAVEL; MECH ENG [440 h] | 53,492.8 | FENKER H | 1 | 1 | HOWARD F |  |  |  |  |  |  |  |  |  |  |  |  |  |  | 13-006 |  |  |  |  |  |  |  |  |  | 243128P6LOE |  | E |  |  | 13-015 | PR |  |  | PE | PE | 14-001 |  |
| 24312914LOE |  | Q1- FY14 Proj Mngmnt H-C upgrade |  | 247d | 2013-10-01 | 2014-09-30 | 24312913LOE | 439d | 0d |  | 8/5 M-F w/JLAB Holidays ReBaseline | SCIENTIST [880 h] | 66,158.4 | FENKER H | 1 | 1 | HOWARD F |  |  |  |  |  |  |  |  |  |  |  |  |  |  | 13-006 |  |  |  |  |  |  |  |  |  | 24312914LOE |  | E |  |  | 13-015 | PR |  |  | PE |  | 14-001 |  |
| 243128PC13LOE5 |  | Q1- Contract Oversight Consultant |  | 127d | 2014-02-03 | 2014-07-31 | 243128PC13LOE, 9-130M FS+228d | 784d | 846d |  | 8/5 M-F w/JLAB Holidays ReBaseline | PROCUREMENT<$50K 60 | 8,255.2 | FENKER H | 1 | 1 | HOWARD F |  |  |  |  |  |  |  |  |  |  |  |  |  |  | 13-006 |  |  |  |  |  |  |  |  |  | 243128PC13LOE |  | E | OB |  | 13-015 | PR |  |  |  |  | 14-001 |  |
| 24312052M |  | Factory Low Current Mag Test of Q1 Complete | milestone | 0d | 2014-06-30 | 2014-06-30 | 24312041a, 24312048 | 367d | 39d |  | 8/5 M-F w/JLAB Holidays ReBaseline |  |  | FENKER H | 1 | 1 | HOWARD F |  | 12-012 |  |  |  | 09-041 |  |  |  |  |  | 10-067 | 10-069 | 11-026 | 13-006F | 11-046 | 12-003 |  |  |  |  |  |  |  | 24312052M |  | M |  |  | 13-015 | PR |  |  |  |  |  |  |
| 24312053M |  | Q1 Delivered to JLab | milestone | 0d | 2014-06-30 | 2014-06-30 | 24312050, 24312047, 24312048, 24312046 FS-18d | 87d | 0d |  | 8/5 M-F w/JLAB Holidays ReBaseline |  |  | FENKER H | 1 | 1 | HOWARD F |  | 12-012 |  |  |  | 09-041 |  |  |  |  |  | 10-067 | 10-069 | 11-026 | 13-006 | 11-046 | 12-003 |  |  |  | 12-036 |  |  |  | 24312053M |  | M |  |  | 13-015 | PR |  |  |  |  |  |  |
| 24312050d |  | Q1 Drawing Validation |  | 100d | 2014-07-01 | 2014-11-19 | 24312050, 24312053M | 268d |  |  | 8/5 M-F w/JLAB Holidays ReBaseline | MECH DES [480 h] | 24,624 | FENKER H | 1 | 1 | HOWARD F |  |  |  | 08-048 | 09-022 | 09-041 |  |  |  |  | 09-012 |  | 10-069 | 11-026 | 13-006 |  | 12-003 | 10-001A |  |  | 12-036 |  |  |  | 24312050d |  | S |  |  | 13-015 | PR |  |  | PE |  | 14-001 | Pat |
| 24312051M |  | Q1 Acceptance Test Complete | milestone | 0d | 2014-08-25 | 2014-08-25 | 28231005 | 294d | 0d |  | 8/5 M-F w/JLAB Holidays ReBaseline |  |  | FENKER H | 1 | 1 | HOWARD F |  | 12-012 |  | 08-048 | 09-022 | 09-041 |  |  |  |  | 09-012 | 10-067 | 10-069 | 11-026 | 13-006 | 11-046 | 12-003 |  |  |  | 12-036 |  |  |  | 24312051M |  | M |  |  | 13-015 | PR |  | 12-054 |  |  |  |  |
| 24312055 |  | Pay Profit on Q1 |  | 1d | 2014-08-26 | 2014-08-26 | 24312060, 24312051M, 24312050, 24312052M | 328d |  |  | 8/5 M-F w/JLAB Holidays ReBaseline |  |  | FENKER H | 1 | 1 | HOWARD F |  | 12-012 |  |  |  |  |  |  |  |  |  | 10-067 | 10-069 | 11-026 | 13-006 |  | 12-003 |  |  |  | 12-036 |  |  | NO RESOURCES | 24312055 |  | Z |  |  | 13-015 | PR |  | 12-054 |  |  |  |  |
| 243128P6LOE5 |  | Q1- P-7 Contract Mngmnt for Q1 |  | 55d | 2014-10-01 | 2014-12-18 | 243128P6LOE, 243128P5TLOE | 249d |  |  | 8/5 M-F w/JLAB Holidays ReBaseline | TRAVEL; MECH ENG [110 h] | 8,213.7 | FENKER H | 1 | 1 | HOWARD F |  |  |  |  |  |  |  |  |  |  |  |  |  |  | 13-006 |  |  |  |  |  |  |  |  |  | 243128P6LOE5 |  | E |  |  | 13-015 | PR |  |  | PE | PE | 14-001 |  |
| 24312915LOE |  | Q1- FY15 Proj Mngmnt H-C upgrade |  | 246d | 2014-10-01 | 2015-09-30 | 24312914LOE | 439d | 0d |  | 8/5 M-F w/JLAB Holidays ReBaseline | SCIENTIST [880 h] | 66,158.4 | FENKER H | 1 | 1 | HOWARD F |  |  |  |  |  |  |  |  |  |  |  |  |  |  | 13-006 |  |  |  |  |  |  |  |  |  | 24312915LOE |  | E |  |  | 13-015 | PR |  |  | PE |  | 14-001 |  |
| 24312915LOE5 |  | Q1- FY16 Proj Mngmnt H-C upgrade |  | 57d | 2015-10-01 | 2015-12-22 | 24312915LOE, 24312914LOE | 439d | 501d |  | 8/5 M-F w/JLAB Holidays ReBaseline | SCIENTIST [120 h] | 9,021.6 | FENKER H | 1 | 1 | HOWARD F |  |  |  |  |  |  |  |  |  |  |  |  |  |  | 13-006 |  |  |  |  |  |  |  |  |  | 24312915LOE5 |  | E |  |  | 13-015 | PR |  |  | PE |  | 14-001 |  |

Notes:
- 14312015: Corrective Actions: 07 Mar 2007, Added This Activity to / Match Fy08-15 Master Schedule. PMC

| ID | WBS | Activity | Type | Duration | Start | Finish | Predecessors | Total float | Free float | Constraint | Calendar | Resources | Cost | RESP - Responsibility | STRT%COMP for CM EVM | FNSH%COMP for CM EVM | CR 07-034 | CAM RESPONSIBLE | CR 08-048 | CR 09-022 | CR 10-008 | CR 10-069 | CR 11-017 | CR 11-026 | CR 12-036 | Milestone Level | 12 GEV MAJOR PROCUREMENT CATAGORY | CR 12-012 | CR 09-012 | CR 13-014 | ReBaseline Actuals Adjustment | BOE NOTES | Original Activity ID Rebaseline | Over Under Fixed | EVMS Reporting Codes | CR 13-006 | BOE Procurement | BOE Adder | CR 13-015 | Post Rebaseline | Obligated Prior to Rebaseline | Pat's Code | BOE Labor | BOE Expenses | CR 14-001 |
| --- | --- | --- | --- | --- | --- | --- | --- | --- | --- | --- | --- | --- | --- | --- | --- | --- | --- | --- | --- | --- | --- | --- | --- | --- | --- | --- | --- | --- | --- | --- | --- | --- | --- | --- | --- | --- | --- | --- | --- | --- | --- | --- | --- | --- | --- |
|  | 3 | **1.4.3.1.3 Q2-3 QUADRUPOLE** |  |  | 2009-12-14 | 2016-02-03 |  |  |  |  |  |  |  |  |  |  |  |  |  |  |  |  |  |  |  |  |  |  |  |  |  |  |  |  |  |  |  |  |  |  |  |  |  |  |  |
| 14313P1LOE |  | Q2&3- P-1 Contract Mngmnt for Q2-3 |  | 198d | 2009-12-14 | 2010-09-30 | 9-100M FS+50d | 20d | 0d |  |  | MECH DES [120 h]; MECH ENG [200 h]; TRAVEL | 24,092.73 | FENKER H | 1 | 1 | 07-034 | HOWARD F | 08-048 | 09-022 | 10-008 | 10-069 | 11-017 | 11-026 | 12-036F |  |  |  |  |  |  |  |  |  |  |  |  |  |  |  |  |  |  |  |  |
| 14313P2LOE |  | Q2&3- P-2 Contract Mngmnt for Q2-3 |  | 248d | 2010-10-01 | 2011-09-30 | 14313P1LOE | 20d | 0d |  |  | MECH ENG [440 h]; MECH DES [80 h]; TRAVEL | 44,970.77 | FENKER H | 1 | 1 | 07-034 | HOWARD F | 08-048 | 09-022 |  | 10-069 | 11-017 | 11-026 | 12-036F |  |  |  |  |  |  |  |  |  |  |  |  |  |  |  |  |  |  |  |  |
| 14313000M |  | Q2&3- Award Contract for SHMS Q2/Q3 quadrupoles | milestone | 0d | 2010-10-18 | 2010-10-18 | 9-090M FS+60d, 122312070 | 0d |  | mandatory start 2010-10-18 |  |  |  | FENKER H | 1 | 1 |  | HOWARD F | 08-048 |  | 10-008 |  |  |  |  | 4 |  |  |  |  |  |  |  |  |  |  |  |  |  |  |  |  |  |  |  |
| 14313002 |  | Q2&3- Contractor Expenses |  | 20d | 2010-10-18 | 2010-11-12 | 14313000M | 433d | 0d |  |  | PROCUREMENT>$50K 69 | 75,967.04 | FENKER H | 1 | 1 | 07-034 | HOWARD F | 08-048 |  | 10-008 | 10-069 | 11-017 | 11-026 | 12-036F |  | 4313 | 12-012 |  |  |  |  |  |  |  |  |  |  |  |  |  |  |  |  |  |
| 14313005 |  | Q2&3- Finalize Dsgn for Q2/Q3 Mags Original Expenses |  | 10d | 2010-11-15 | 2010-11-30 | 14313000M, 14313002, 14313002a FS-40d | 433d | 79d |  |  | TRAVEL | 596.76 | FENKER H | 1 | 1 | 07-034 | HOWARD F | 08-048 |  | 10-008 | 10-069 | 11-017 | 11-026 | 12-036F |  | 4313 | 12-012 | 09-012 |  |  |  |  |  |  |  |  |  |  |  |  |  |  |  |  |
| 14313002a |  | Reverse Entry per CR 11-017 |  | 5d | 2010-12-01 | 2010-12-07 | 14313000M FS+30d | 458d | 25d |  |  | PROCUREMENT>$50K 69 | -75,967.04 | FENKER H | 1 | 1 | 07-034 | HOWARD F | 08-048 |  | 10-008 | 10-069 | 11-017 | 11-026 | 12-036F |  | 4313 | 12-012 |  |  |  |  |  |  |  |  |  |  |  |  |  |  |  |  |  |
| 14313006 |  | Vend Fab Q2&3 Peg Point #1 Intermediate Design Review |  | 139d | 2010-12-07 | 2011-06-30 | 14313000M FS+34d | 354d | 0d |  |  | PROCUREMENT<$50K 60 NO ESCALATION; PROCUREMENT>$50K 69 NO ESCALATION | 158,700 | FENKER H | 1 | 1 |  | HOWARD F |  |  |  |  | 11-017 | 11-026 | 12-036F |  | 4313 | 12-012 |  |  |  |  |  |  |  |  |  |  |  |  |  |  |  |  |  |
| 14313010 |  | Vend Fab Q2&3 Peg Point #2a Final Design Review |  | 261d | 2010-12-07 | 2011-12-30 | 14313006 FS-139d, 14313020 FS-139d | 354d | 0d |  |  | PROCUREMENT>$50K 69 NO ESCALATION | 441,300 | FENKER H | 1 | 1 | 07-034 | HOWARD F | 08-048 |  | 10-008 | 10-069 | 11-017 | 11-026 | 12-036F |  | 4313 | 12-012 |  |  |  |  |  |  |  |  |  |  |  |  |  |  |  |  |  |
| 14313015 |  | Vend Fab Q2&3 Peg Point #2b Final Design Review |  | 186d | 2011-04-01 | 2011-12-30 | 14313005, 14313010 FS-186d | 354d | 0d |  |  | PROCUREMENT<$50K 60 NO ESCALATION | 48,400 | FENKER H | 1 | 1 | 07-034 | HOWARD F | 08-048 |  | 10-008 | 10-069 | 11-017 | 11-026 | 12-036F |  | 4313 | 12-012 | 09-012 |  |  |  |  |  |  |  |  |  |  |  |  |  |  |  |  |
| 14313017 |  | Vend Fab Q2&3 Peg Point #3 Cryostat Component Complete |  | 269d | 2011-04-01 | 2012-04-30 | 14315029 FS-225d, 14313030 FS-186d, 14313015 FS-186d | 354d | 0d |  |  | PROCUREMENT<$50K 60 NO ESCALATION; PROCUREMENT>$50K 69 NO ESCALATION | 432,250 | FENKER H | 1 | 1 | 07-034 | HOWARD F | 08-048 | 09-022 | 10-008 | 10-069 | 11-017 | 11-026 | 12-036F |  | 4313 | 12-012 | 09-012 |  |  |  |  |  |  |  |  |  |  |  |  |  |  |  |  |
| 14313018 |  | Vend Fab Q2&3 Peg Point #4a Cold Mass Fiducialitzation |  | 375d | 2011-04-01 | 2012-09-28 | 14315027, 14313017 FS-269d | 518d | 0d |  |  | PROCUREMENT>$50K 69 NO ESCALATION | 319,350 | FENKER H | 1 | 1 | 07-034 | HOWARD F | 08-048 | 09-022 | 10-008 | 10-069 | 11-017 | 11-026 | 12-036F |  | 4313 | 12-012 |  |  |  |  |  |  |  |  |  |  |  |  |  |  |  |  |  |
| 14313020 |  | PDR/IDR Site Inspection |  | 20d | 2011-06-03 | 2011-06-30 | 14313006 FS-20d | 354d | 0d |  |  | MECH ENG [40 h]; TRAVEL | 13,509.61 | FENKER H | 1 | 1 | 07-034 | HOWARD F | 08-048 |  | 10-008 | 10-069 | 11-017 | 11-026 | 12-036F |  |  | 12-012 |  |  |  |  |  |  |  |  |  |  |  |  |  |  |  |  |  |
| 14313P3LOE |  | Q2&3- P-3 Contract Mngmnt for Q2-3 |  | 247d | 2011-10-03 | 2012-09-28 | 14313P2LOE | 20d | 0d |  |  | MECH DES [80 h]; MECH ENG [440 h]; TRAVEL | 41,726.45 | FENKER H | 1 | 1 | 07-034 | HOWARD F | 08-048 | 09-022 |  | 10-069 | 11-017 | 11-026 | 12-036F |  |  |  |  |  |  |  |  |  |  |  |  |  |  |  |  |  |  |  |  |
| 14313030 |  | FDR Site Inspection |  | 20d | 2011-11-28 | 2011-12-30 | 14313015 FS-20d | 354d | 0d |  |  | TRAVEL; MECH ENG [40 h] | 12,164.83 | FENKER H | 1 | 1 | 07-034 | HOWARD F | 08-048 |  | 10-008 | 10-069 | 11-017 | 11-026 | 12-036F |  |  | 12-012 |  |  |  |  |  |  |  |  |  |  |  |  |  |  |  |  |  |
| 14313019 |  | Vend Fab Q2&3 Peg Point #4b Cold Mass Fiducialitzation |  | 127d | 2012-04-02 | 2012-09-28 | 14313018 FS-127d | 518d | 0d |  |  | PROCUREMENT>$50K 69 NO ESCALATION; PROCUREMENT<$50K 60 NO ESCALATION | 112,900 | FENKER H | 1 | 1 |  | HOWARD F |  |  |  |  | 11-017 | 11-026 | 12-036F |  | 4313 | 12-012 |  |  |  |  |  |  |  |  |  |  |  |  |  |  |  |  |  |
| 14313019a |  | Vend Fab Q2&3 Peg Point #5 Shipment |  | 333d | 2012-04-02 | 2013-07-31 | 14313019 FS-127d | 518d | 512d |  |  | PROCUREMENT>$50K 69 NO ESCALATION | 1,321,000 | FENKER H | 1 | 1 |  | HOWARD F |  |  |  |  | 11-017 | 11-026 | 12-036F |  | 4313 | 12-012 |  |  |  |  |  |  |  |  |  |  |  |  |  |  |  |  |  |
| 14313220 |  | Q2 and Q3 Coil Inspection |  | 20d | 2012-04-03 | 2012-04-30 | 14313017 FS-20d | 354d |  |  |  | TRAVEL; MECH ENG [40 h] | 7,484.82 | FENKER H | 1 | 1 | 07-034 | HOWARD F | 08-048 |  | 10-008 | 10-069 | 11-017 | 11-026 | 12-036F |  |  | 12-012 |  |  |  |  |  |  |  |  |  |  |  |  |  |  |  |  |  |
| 14313P4LOE |  | Q2&3- P-4 Contract Mngmnt for Q2-3 |  | 228d | 2012-10-01 | 2013-08-30 | 14313P3LOE | 20d |  |  |  | MECH DES [73.55 h]; MECH ENG [404.51 h]; TRAVEL | 44,310.76 | FENKER H | 1 | 1 | 07-034 | HOWARD F | 08-048 | 09-022 |  | 10-069 | 11-017 | 11-026 | 12-036F |  |  | 12-012 |  | 13-014 |  |  |  |  |  |  |  |  |  |  |  |  |  |  |  |
| 14313280 |  | Re-Baseline Actuals Adjustment |  | 1d | 2013-08-30 | 2013-08-30 | 9-130M FS+227d | 20d |  |  |  | PROCUREMENT>$50K 69 NO ESCALATION | -2,650,807.51 | FENKER H | 1 | 1 |  | HOWARD F |  |  |  |  |  |  |  |  |  |  |  | 13-014 | ADJ |  |  |  |  |  |  |  |  |  |  |  |  |  |  |
| 24313015 |  | Vend Fab Q2&3 Peg Point #2 Final Design Review |  | 43d | 2013-09-03 | 2013-10-31 | 9-130M FS+228d | 1d | 0d |  | 8/5 M-F w/JLAB Holidays ReBaseline | PROCUREMENT<$50K 60 NO ESCALATION; PROCUREMENT>$50K 69 NO ESCALATION | 489,700.13 | FENKER H | 1 | 1 | 07-034 | HOWARD F | 08-048 |  | 10-008 | 10-069 | 11-017 | 11-026 | 12-036F |  | 4313 | 12-012 | 09-012 |  |  | OPEN OBLIGATION | 24313015 | y | P | 13-006F | OB | YES | 13-015 | PR | OB |  |  |  |  |
| 24313017 |  | Vend Fab Q2&3 Peg Point #3 Cryostat Component Complete |  | 408d | 2013-09-03 | 2015-04-30 | 24313015 FS-43d, 24313030a FS-186d, 24313030 FS-186d | 1d | 0d |  | 8/5 M-F w/JLAB Holidays ReBaseline | PROCUREMENT<$50K 60 NO ESCALATION; PROCUREMENT>$50K 69 NO ESCALATION | 432,250 | FENKER H | 1 | 1 | 07-034 | HOWARD F | 08-048 | 09-022 | 10-008 | 10-069 | 11-017 | 11-026 | 12-036F |  | 4313 | 12-012 | 09-012 |  |  | OPEN OBLIGATION | 24313017 | y | P | 13-006F | OB | YES | 13-015 | PR | OB |  |  |  |  |
| 24313019 |  | Vend Fab Q2&3 Peg Point #4 Cold Mass Fiducialitzation |  | 449d | 2013-09-03 | 2015-06-30 | 24313017 FS-408d | 6d | 0d |  | 8/5 M-F w/JLAB Holidays ReBaseline | PROCUREMENT>$50K 69 NO ESCALATION; PROCUREMENT<$50K 60 NO ESCALATION | 432,250 | FENKER H | 1 | 1 |  | HOWARD F |  |  |  |  | 11-017 | 11-026 | 12-036F |  | 4313 | 12-012 |  |  |  | OPEN OBLIGATION | 24313019 | y | P | 13-006F | OB | YES | 13-015 | PR | OB |  |  |  |  |
| 24313019a |  | Vend Fab Q2&3 Peg Point #5 Shipment |  | 513d | 2013-09-03 | 2015-09-30 | 24313019 FS-449d | 6d | 0d |  | 8/5 M-F w/JLAB Holidays ReBaseline | PROCUREMENT>$50K 69 NO ESCALATION | 1,321,000 | FENKER H | 1 | 1 |  | HOWARD F |  |  |  |  | 11-017 | 11-026 | 12-036F |  | 4313 | 12-012 |  |  |  | OPEN OBLIGATION | 24313019a | y | P | 13-006 | OB | YES | 13-015 | PR | OB |  |  |  |  |
| 24313019b |  | Vend Fab Q2&3 Peg Point #6 Final Acceptance |  | 571d | 2013-09-03 | 2015-12-23 | 24313235 FS-679d, 24313019a FS-513d | 64d | 36d |  | 8/5 M-F w/JLAB Holidays ReBaseline | PROCUREMENT>$50K 69 NO ESCALATION | 146,100 | FENKER H | 1 | 1 |  | HOWARD F |  |  |  |  | 11-017 | 11-026 | 12-036F |  | 4313 |  |  |  |  | OPEN OBLIGATION | 24313019b | y | P | 13-006 | OB | YES | 13-015 | PR | OB |  |  |  |  |
| 24313280 |  | Planning Package SigmaPhi Quads (second winding station) |  | 161d | 2013-09-03 | 2014-04-30 | 9-130M FS+228d | 460d | 432d |  | 8/5 M-F w/JLAB Holidays ReBaseline | PROCUREMENT>$50K 69 NO ESCALATION | 100,000 | FENKER H | 1 | 1 |  | HOWARD F |  |  |  |  |  |  |  |  |  |  |  |  |  |  | 24313280 | y | D | 13-006 | EV |  | 13-015 | PR | OB | Pat |  |  |  |
| 24313P4LOE |  | Q2&3- P-4 Contract Mngmnt for Q2-3 |  | 20d | 2013-09-03 | 2013-09-30 | 9-130M FS+228d | 354d | 0d |  | 8/5 M-F w/JLAB Holidays ReBaseline | MECH DES [6.45 h]; MECH ENG [35.47 h]; TRAVEL | 3,885.66 | FENKER H | 1 | 1 | 07-034 | HOWARD F | 08-048 | 09-022 |  | 10-069 | 11-017 | 11-026 | 12-036F |  |  | 12-012 |  |  |  | OPEN OBLIGATION | 24313P4LOE |  | E | 13-006F |  |  | 13-015 | PR |  |  | PE | PE |  |
| 24313030 |  | FDR Site Inspection FY13 |  | 17d | 2013-09-06 | 2013-09-30 | 24313015 FS-40d | 164d | 0d |  | 8/5 M-F w/JLAB Holidays ReBaseline | MECH ENG [34 h]; TRAVEL | 10,416.27 | FENKER H | 1 | 1 | 07-034 | HOWARD F | 08-048 |  | 10-008 | 10-069 | 11-017 | 11-026 | 12-036F |  |  | 12-012 |  |  |  |  | 24313030 |  | H | 13-006F |  |  | 13-015 | PR |  |  | PE | PE |  |
| 24313030a |  | FDR Site Inspection FY14 |  | 3d | 2013-10-01 | 2013-10-03 | 24313015 FS-40d, 24313030 | 164d | 163d |  | 8/5 M-F w/JLAB Holidays ReBaseline | TRAVEL; MECH ENG [6 h] | 1,896.81 | FENKER H | 1 | 1 | 07-034 | HOWARD F | 08-048 |  | 10-008 | 10-069 | 11-017 | 11-026 | 12-036F |  |  | 12-012 |  |  |  |  | 24313030 |  | H | 13-006F |  |  | 13-015 | PR |  |  | PE | PE | 14-001 |
| 24313P5LOE |  | Q2&3- P-5 Contract Mngmnt for Q2-3 |  | 247d | 2013-10-01 | 2014-09-30 | 24313P4LOE | 354d | 0d |  | 8/5 M-F w/JLAB Holidays ReBaseline | MECH DES [20 h]; MECH ENG [440 h]; TRAVEL | 40,269.71 | FENKER H | 1 | 1 | 07-034 | HOWARD F | 08-048 | 09-022 |  | 10-069 | 11-017 | 11-026 | 12-036F |  |  | 12-012 |  |  |  |  | 24313P5LOE |  | E | 13-006 |  |  | 13-015 | PR |  |  | PE | PE | 14-001 |
| 24313P6LOE |  | Q2&3- P-6 Contract Mngmnt for Q2-3 |  | 247d | 2014-10-01 | 2015-10-01 | 24313P5LOE | 439d | 0d |  | 8/5 M-F w/JLAB Holidays ReBaseline | MECH ENG [440 h]; TRAVEL | 53,492.8 | FENKER H | 1 | 1 |  | HOWARD F |  |  |  |  |  |  |  |  |  |  |  |  |  |  | 24313P6LOE |  | E | 13-006 |  |  | 13-015 | PR |  |  | PE | PE | 14-001 |
| 24313220 |  | Q2 and Q3 Coil Inspection |  | 49d | 2014-10-27 | 2015-01-15 | 24313017 FS-123d | 287d | 259d |  | 8/5 M-F w/JLAB Holidays ReBaseline | TRAVEL; MECH ENG [40 h] | 7,816.11 | FENKER H | 1 | 1 | 07-034 | HOWARD F | 08-048 |  | 10-008 | 10-069 | 11-017 | 11-026 | 12-036F |  |  | 12-012 |  |  |  |  | 24313220 |  | H |  |  |  | 13-015 | PR |  |  | PE | PE | 14-001 |
| 24313230 |  | Q2 and Q3- Insp Cold Mass |  | 6d | 2014-12-22 | 2015-01-08 | 24313019 FS-126d, 2-30M FS-240d | 292d | 264d |  | 8/5 M-F w/JLAB Holidays ReBaseline | TRAVEL; MECH ENG [40 h] | 7,970.16 | FENKER H | 1 | 1 | 07-034 | HOWARD F | 08-048 |  | 10-008 | 10-069 | 11-017 | 11-026 | 12-036F |  |  | 12-012 |  |  |  |  | 24313230 |  | H | 13-006 |  |  | 13-015 | PR |  |  | PE | PE | 14-001 |
| 24313235 |  | Q2 and Q3 witness Pressure Tests |  | 36d | 2015-05-08 | 2015-06-30 | 24313019a FS-100d, 2-31M FS-100d, 2-30M FS-40d | 294d | 230d |  | 8/5 M-F w/JLAB Holidays ReBaseline | TRAVEL | 4,983.36 | FENKER H | 1 | 1 | 07-034 | HOWARD F | 08-048 |  |  | 10-069 | 11-017 | 11-026 | 12-036 |  | 4313 |  | 09-012 |  |  | NO PROC. | 24313235 |  | H | 13-006 |  |  | 13-015 | PR |  |  |  | PE | 14-001 |
| 24313275 |  | Q2&Q3 Drawing Validation |  | 100d | 2015-09-02 | 2016-02-03 | 24313019a FS-20d, 2-31M FS-20d, 2-30M | 28d | 0d |  | 8/5 M-F w/JLAB Holidays ReBaseline | MECH DES [480 h] | 24,624 | FENKER H | 1 | 1 | 07-034 | HOWARD F | 08-048 | 09-022 |  | 10-069 | 11-017 | 11-026 | 12-036 |  |  |  | 09-012 |  |  |  | 24313275 |  | S | 13-006 |  |  | 13-015 | PR |  | Pat | PE |  | 14-001 |
| 24313P6LOE5 |  | Q2&3- P-7 Contract Mngmnt for Q2-3 |  | 56d | 2015-10-02 | 2015-12-22 | 24313P6LOE, 24313P5LOE | 439d | 501d |  | 8/5 M-F w/JLAB Holidays ReBaseline | MECH ENG [110 h] | 8,213.7 | FENKER H | 1 | 1 |  | HOWARD F |  |  |  |  |  |  |  |  |  |  |  |  |  |  | 24313P6LOE5 |  | E | 13-006 |  |  | 13-015 | PR |  |  | PE | PE | 14-001 |
| 24313270M |  | Q2 and Q3 Contract complete | milestone | 0d | 2016-02-03 | 2016-02-03 | 28236010, 24313280, 24313019b FS-14d, 28236020, 24313275, 24313230, 24313220, 24313P5LOE | 28d |  |  | 8/5 M-F w/JLAB Holidays ReBaseline |  |  | FENKER H | 1 | 1 | 07-034 | HOWARD F | 08-048 | 09-022 |  | 10-069 | 11-017 | 11-026 | 12-036 |  |  | 12-012 | 09-012 |  |  |  | 24313270M |  | M | 13-006 |  |  | 13-015 | PR |  |  |  |  |  |

| ID | WBS | Activity | Type | Duration | Start | Finish | Predecessors | Total float | Free float | Constraint | Calendar | Resources | Cost | RESP - Responsibility | STRT%COMP for CM EVM | FNSH%COMP for CM EVM | CR 07-034 | CAM RESPONSIBLE | CR 08-048 | CR 09-022 | CR 10-008 | CR 10-069 | CR 11-026 | CR 13-006 | Milestone Level | Profile change | 12 GEV MAJOR PROCUREMENT CATAGORY | CR 09-012 | CR 10-076 | CR 11-017 | CR 11-046 | CR 12-012 | CR 12-036 | CR 08-052 | CR 13-014 | ReBaseline Actuals Adjustment | BOE NOTES | Original Activity ID Rebaseline | Over Under Fixed | EVMS Reporting Codes | BOE Procurement | BOE Adder | CR 13-015 | Post Rebaseline | Obligated Prior to Rebaseline | BOE Labor | BOE Expenses | CR 14-001 | CR 12-054 | Pat's Code |
| --- | --- | --- | --- | --- | --- | --- | --- | --- | --- | --- | --- | --- | --- | --- | --- | --- | --- | --- | --- | --- | --- | --- | --- | --- | --- | --- | --- | --- | --- | --- | --- | --- | --- | --- | --- | --- | --- | --- | --- | --- | --- | --- | --- | --- | --- | --- | --- | --- | --- | --- |
|  | 4 | **1.4.3.1.4 DIPOLE** |  |  | 2009-12-14 | 2015-10-01 |  |  |  |  |  |  |  |  |  |  |  |  |  |  |  |  |  |  |  |  |  |  |  |  |  |  |  |  |  |  |  |  |  |  |  |  |  |  |  |  |  |  |  |  |
| 14314P1LOE |  | Dipole- P-1 Contract Mngmnt for Dipole |  | 198d | 2009-12-14 | 2010-09-30 | 9-100M FS+50d | 573d | 0d |  |  | MECH DES [120 h]; MECH ENG [280 h]; TRAVEL | 32,657.08 | FENKER H | 1 | 1 | 07-034 | HOWARD F | 08-048 | 09-022 | 10-008 | 10-069 | 11-026 | 13-006F |  |  |  |  |  |  |  |  |  |  |  |  |  |  |  |  |  |  |  |  |  |  |  |  |  |  |
| 14314000M5 |  | Dipole- Award Contract for SHMS Dipole Mag | milestone | 0d | 2010-08-02 | 2010-08-02 | 9-090M FS+63d, 122312070 | 0d |  | mandatory start 2010-08-02 |  |  |  | FENKER H | 1 | 1 |  | HOWARD F | 08-048 |  | 10-008 |  |  |  | 4 | C |  |  |  |  |  |  |  |  |  |  |  |  |  |  |  |  |  |  |  |  |  |  |  |  |
| 14314002 |  | Dipole- Finalize Dsgn for Dipole Mag (Original Expenses) |  | 22d | 2010-08-02 | 2010-08-31 | 14314000M5 | 139d | 20d |  |  | TRAVEL | 859.49 | FENKER H | 1 | 1 | 07-034 | HOWARD F | 08-048 |  | 10-008 | 10-069 | 11-026 |  |  |  | 4314 | 09-012 | 10-076 | 11-017 | 11-046 | 12-012 | 12-036F |  |  |  |  |  |  |  |  |  |  |  |  |  |  |  |  |  |
| 14314003 |  | Dipole- Contractor Expenses |  | 20d | 2010-08-02 | 2010-08-27 | 14314000M5 | 119d | 0d |  |  | PROCUREMENT>$50K 69 | 59,334.4 | FENKER H | 1 | 1 | 07-034 | HOWARD F | 08-048 |  | 10-008 | 10-069 | 11-026 |  |  |  | 4314 |  | 10-076 | 11-017 | 11-046 | 12-012 | 12-036F |  |  |  |  |  |  |  |  |  |  |  |  |  |  |  |  |  |
| 14314003a |  | Dipole Contractor Expenses - Reverse Entry |  | 1d | 2010-09-30 | 2010-09-30 | 14314003 FS+22d | 119d | 0d |  |  | PROCUREMENT>$50K 69 | -59,334.4 | FENKER H | 1 | 1 |  | HOWARD F |  |  |  |  | 11-026 |  |  |  |  |  | 10-076 | 11-017 | 11-046 | 12-012 | 12-036F |  |  |  |  |  |  |  |  |  |  |  |  |  |  |  |  |  |
| 14314004 |  | Vend Fab Dipole Intermediate Design Review Peg Point #1 |  | 163d | 2010-09-30 | 2011-05-31 | 9-110M FS-1d, 14314003, 14314002, 14314003a FS-1d | 119d | 0d |  |  | PROCUREMENT<$50K 60 NO ESCALATION; PROCUREMENT>$50K 69 NO ESCALATION | 97,500 | FENKER H | 1 | 1 | 07-034 | HOWARD F | 08-048 |  | 10-008 | 10-069 | 11-026 |  |  |  | 4314 |  | 10-076 | 11-017 | 11-046 | 12-012 | 12-036F |  |  |  |  |  |  |  |  |  |  |  |  |  |  |  |  |  |
| 14314010 |  | Vend Fab Dipole Coil Tooling Delivered Peg Point #2 |  | 249d | 2010-09-30 | 2011-09-30 | 14314004 FS-163d, 14314036 FS-163d | 119d | 0d |  |  | PROCUREMENT>$50K 69 NO ESCALATION | 461,520 | FENKER H | 1 | 1 | 07-034 | HOWARD F | 08-048 |  | 10-008 | 10-069 | 11-026 |  |  |  | 4314 | 09-012 | 10-076 | 11-017 | 11-046 | 12-012 | 12-036F |  |  |  |  |  |  |  |  |  |  |  |  |  |  |  |  |  |
| 14314012 |  | Vend Fab Dipole Final Design Review Peg Point #3 |  | 269d | 2010-09-30 | 2011-10-28 | 14314010 FS-249d, 14315020 FS-182d | 119d | 0d |  |  | PROCUREMENT>$50K 69 NO ESCALATION | 97,500 | FENKER H | 1 | 1 | 07-034 | HOWARD F | 08-048 | 09-022 | 10-008 | 10-069 | 11-026 |  |  |  | 4314 | 09-012 | 10-076 | 11-017 | 11-046 | 12-012 | 12-036F |  |  |  |  |  |  |  |  |  |  |  |  |  |  |  |  |  |
| 14314015 |  | Vend Fab Dipole Second Coil Wind Peg Point #4a |  | 369d | 2010-09-30 | 2012-03-30 | 14314045 FS-269d, 14314012 FS-269d | 119d | 0d |  |  | PROCUREMENT>$50K 69 NO ESCALATION | 43,480 | FENKER H | 1 | 1 | 07-034 | HOWARD F | 08-048 |  | 10-008 | 10-069 | 11-026 |  |  |  |  |  | 10-076 | 11-017 | 11-046 | 12-012 | 12-036F |  |  |  |  |  |  |  |  |  |  |  |  |  |  |  |  |  |
| 14314P2LOE |  | Dipole- P-2 Contract Mngmnt for Dipole |  | 248d | 2010-10-01 | 2011-09-30 | 14314P1LOE | 573d | 0d |  |  | TRAVEL; MECH DES [80 h]; MECH ENG [440 h] | 42,703.09 | FENKER H | 1 | 1 | 07-034 | HOWARD F | 08-048 | 09-022 |  | 10-069 | 11-026 | 13-006F |  |  |  |  |  |  |  |  |  |  |  |  |  |  |  |  |  |  |  |  |  |  |  |  |  |  |
| 14314020 |  | Vend Fab Dipole Second Coil Wind Peg Point #4b |  | 248d | 2011-04-01 | 2012-03-30 | 9-110M FS+120d, 14314015 FS-248d | 119d | 0d |  |  | PROCUREMENT<$50K 60 NO ESCALATION; PROCUREMENT>$50K 69 NO ESCALATION | 348,450 | FENKER H | 1 | 1 | 07-034 | HOWARD F | 08-048 |  | 10-008 | 10-069 | 11-026 |  |  | C | 4314 | 09-012 | 10-076 | 11-017 | 11-046 | 12-012 | 12-036F |  |  |  |  |  |  |  |  |  |  |  |  |  |  |  |  |  |
| 14314025 |  | Vend Fab Dipole Outer Vessel Completed Peg Point #5a |  | 291d | 2011-04-01 | 2012-05-31 | 14314047 FS-487d, 14314020 FS-248d | 119d | 0d |  |  | PROCUREMENT>$50K 69 NO ESCALATION | 251,550 | FENKER H | 1 | 1 | 07-034 | HOWARD F | 08-048 |  | 10-008 | 10-069 | 11-026 |  |  |  | 4314 | 09-012 | 10-076 | 11-017 | 11-046 | 12-012 | 12-036F |  |  |  |  |  |  |  |  |  |  |  |  |  |  |  |  |  |
| 14314036 |  | Dipole- Intermediate Design Review |  | 20d | 2011-05-03 | 2011-05-31 | 14314004 FS-20d | 119d | 0d |  |  | MECH ENG [40 h]; TRAVEL | 7,253.34 | FENKER H | 1 | 1 | 07-034 | HOWARD F | 08-048 | 09-022 | 10-008 | 10-069 | 11-026 |  |  |  | 4314 |  | 10-076 | 11-017 | 11-046 | 12-012 | 12-036F |  |  |  |  |  |  |  |  |  |  |  |  |  |  |  |  |  |
| 14314045 |  | Dipole- Final Design Review |  | 20d | 2011-10-03 | 2011-10-28 | 14314012 FS-20d | 119d | 0d |  |  | MECH ENG [40 h]; TRAVEL | 7,484.82 | FENKER H | 1 | 1 | 07-034 | HOWARD F | 08-048 |  | 10-008 | 10-069 | 11-026 |  |  |  | 4314 | 09-012 | 10-076 | 11-017 | 11-046 | 12-012 | 12-036F |  |  |  |  |  |  |  |  |  |  |  |  |  |  |  |  |  |
| 14314P3LOE |  | Dipole- P-3 Contract Mngmnt for Dipole |  | 247d | 2011-10-03 | 2012-09-28 | 14314P2LOE | 573d | 0d |  |  | MECH ENG [440 h]; TRAVEL; MECH DES [80 h] | 44,066.45 | FENKER H | 1 | 1 | 07-034 | HOWARD F | 08-048 | 09-022 |  | 10-069 | 11-026 | 13-006F |  |  |  |  |  |  |  |  |  |  |  |  |  |  |  |  |  |  |  |  |  |  |  |  |  |  |
| 14314047 |  | Dipole Inspect Coil |  | 20d | 2012-03-05 | 2012-03-30 | 14314020 FS-20d | 358d | 239d |  |  | MECH ENG [40 h]; TRAVEL | 7,484.82 | FENKER H | 1 | 1 | 07-034 | HOWARD F | 08-048 | 09-022 |  | 10-069 | 11-026 |  |  |  | 4314 |  | 10-076 | 11-017 | 11-046 | 12-012 | 12-036F | 08-052 |  |  |  |  |  |  |  |  |  |  |  |  |  |  |  |  |
| 14314027 |  | Vend Fab Dipole Outer Vessel Completed Peg Point #5b |  | 43d | 2012-04-02 | 2012-05-31 | 14314020 FS-20d, 14314047 FS-245d, 14314025 FS-43d, 9-120M FS+120d | 119d | 0d |  |  | PROCUREMENT<$50K 60 NO ESCALATION; PROCUREMENT>$50K 69 NO ESCALATION | 185,325 | FENKER H | 1 | 1 | 07-034 | HOWARD F | 08-048 |  | 10-008 | 10-069 | 11-026 |  |  |  |  |  | 10-076 | 11-017 | 11-046 | 12-012 | 12-036F |  |  |  |  |  |  |  |  |  |  |  |  |  |  |  |  |  |
| 14314030 |  | Vend Fab Dipole Factory Test Completed Peg Point #6 |  | 226d | 2012-04-02 | 2013-02-28 | 14314027 FS-43d | 119d | 0d |  |  | PROCUREMENT>$50K 69 NO ESCALATION | 333,300 | FENKER H | 1 | 1 | 07-034 | HOWARD F | 08-048 |  | 10-008 | 10-069 | 11-026 |  |  |  | 4314 | 09-012 | 10-076 | 11-017 | 11-046 | 12-012 | 12-036F |  |  |  |  |  |  |  |  |  |  |  |  |  |  |  |  |  |
| 14314P4LOE |  | Dipole- P-4 Contract Mngmnt for Dipole |  | 228d | 2012-10-01 | 2013-08-30 | 14314P3LOE | 573d | 0d |  |  | MECH ENG [294.19 h]; TRAVEL; MECH DES [73.55 h] | 36,327.99 | FENKER H | 1 | 1 | 07-034 | HOWARD F | 08-048 | 09-022 |  | 10-069 | 11-026 | 13-006F |  |  |  |  |  |  |  | 12-012 |  |  | 13-014 |  |  |  |  |  |  |  |  |  |  |  |  |  |  |  |
| 14314100 |  | Planning Package SigmaPhi Phase 1 (Coil Developement) |  | 61d | 2013-01-02 | 2013-03-29 | 9-130M FS+59d | 128d |  |  |  | PROCUREMENT>$50K 69 NO ESCALATION | 250,000 | FENKER H | 1 | 1 |  | HOWARD F |  |  |  |  |  | 13-006 |  |  | 4314 |  |  |  |  |  |  |  |  |  |  |  |  |  |  |  |  |  |  |  |  |  |  |  |
| 14314P4TLOE |  | Dipole- P-4 Contract Extra Travel |  | 169d | 2013-01-02 | 2013-08-30 | 14314P4LOE FS-169d | 573d |  |  |  | TRAVEL | 13,233.86 | FENKER H | 1 | 1 |  | HOWARD F |  |  |  |  |  | 13-006 |  |  |  |  |  |  |  |  |  |  | 13-014 |  |  |  |  |  |  |  |  |  |  |  |  |  |  |  |
| 14314030a |  | Dipole Magnet Shipping |  | 30d | 2013-03-01 | 2013-04-11 | 14314030 | 119d |  |  |  |  |  | FENKER H | 1 | 1 | 07-034 | HOWARD F | 08-048 | 09-022 |  | 10-069 | 11-026 |  |  |  | 4314 |  | 10-076 | 11-017 | 11-046 | 12-012 | 12-036 | 08-052 |  |  |  |  |  |  |  |  |  |  |  |  |  |  |  |  |
| 14314115 |  | Re-Baseline Actuals Adjustment |  | 1d | 2013-08-30 | 2013-08-30 | 9-130M FS+227d | 20d |  |  |  | PROCUREMENT>$50K 69 NO ESCALATION | -944,650.63 | FENKER H | 1 | 1 |  | HOWARD F |  |  |  |  |  |  |  |  |  |  |  |  |  |  |  |  | 13-014 | ADJ |  |  |  |  |  |  |  |  |  |  |  |  |  |  |
| 24314012 |  | Vend Fab Dipole Final Design Review Peg Point #3 |  | 43d | 2013-09-03 | 2013-10-31 | 9-130M FS+228d | 0d |  |  | 8/5 M-F w/JLAB Holidays ReBaseline | PROCUREMENT<$50K 60 NO ESCALATION; PROCUREMENT>$50K 69 NO ESCALATION | 97,500 | FENKER H | 1 | 1 | 07-034 | HOWARD F | 08-048 | 09-022 | 10-008 | 10-069 | 11-026 | 13-006F |  |  | 4314 | 09-012 | 10-076 | 11-017 | 11-046 | 12-012 | 12-036F |  |  |  | OPEN OBLIGATION | 24314012 | y | P | OB | YES | 13-015 | PR | OB |  |  |  |  |  |
| 24314020 |  | Vend Fab Dipole Second Coil Wind Peg Point #4 |  | 139d | 2013-09-03 | 2014-03-31 | 24314012 FS-43d | 0d |  |  | 8/5 M-F w/JLAB Holidays ReBaseline | PROCUREMENT<$50K 60 NO ESCALATION; PROCUREMENT>$50K 69 NO ESCALATION | 391,930 | FENKER H | 1 | 1 | 07-034 | HOWARD F | 08-048 |  | 10-008 | 10-069 | 11-026 | 13-006F |  | C | 4314 | 09-012 | 10-076 | 11-017 | 11-046 | 12-012 | 12-036F |  |  |  | OPEN OBLIGATION | 24314020 | y | P | OB | YES | 13-015 | PR | OB |  |  |  |  |  |
| 24314027 |  | Vend Fab Dipole Outer Vessel Completed Peg Point #5 (F-12) |  | 267d | 2013-09-03 | 2014-09-30 | 24314047 FS-245d, 24314020 FS-139d | 0d |  |  | 8/5 M-F w/JLAB Holidays ReBaseline | PROCUREMENT<$50K 60 NO ESCALATION; PROCUREMENT>$50K 69 NO ESCALATION | 436,875 | FENKER H | 1 | 1 | 07-034 | HOWARD F | 08-048 |  | 10-008 | 10-069 | 11-026 | 13-006F |  |  |  |  | 10-076 | 11-017 | 11-046 | 12-012 | 12-036F |  |  |  | OPEN OBLIGATION | 24314027 | y | P | OB | YES | 13-015 | PR | OB |  |  |  |  |  |
| 24314028 |  | Vend Fab Dipole 4K Testing Peg Point #5a |  | 77d | 2013-09-03 | 2013-12-20 | 24314027 FS-267d | 0d |  |  | 8/5 M-F w/JLAB Holidays ReBaseline | PROCUREMENT<$50K 60 NO ESCALATION | 26,000.03 | FENKER H | 1 | 1 | 07-034 | HOWARD F | 08-048 |  | 10-008 | 10-069 | 11-026 | 13-006F |  |  |  |  | 10-076 | 11-017 | 11-046 | 12-012 | 12-036F |  |  |  | OPEN OBLIGATION | 24314027 | y | P | OB | YES | 13-015 | PR | OB |  |  |  |  |  |
| 24314030 |  | Vend Fab Dipole Factory Test Completed Peg Point #6 |  | 386d | 2013-09-03 | 2015-03-31 | 24314027 FS-267d, 24314028 FS-77d | 0d |  |  | 8/5 M-F w/JLAB Holidays ReBaseline | PROCUREMENT>$50K 69 NO ESCALATION | 333,300 | FENKER H | 1 | 1 | 07-034 | HOWARD F | 08-048 |  | 10-008 | 10-069 | 11-026 | 13-006 |  |  | 4314 | 09-012 | 10-076 | 11-017 | 11-046 | 12-012 | 12-036F |  |  |  | OPEN OBLIGATION | 24314030 | y | P | OB | YES | 13-015 | PR | OB |  |  |  |  |  |
| 24314035 |  | Vend Fab Dipole Magnet Accepted Peg Point #7 |  | 492d | 2013-09-03 | 2015-08-31 | 24314030 FS-386d | 1d |  |  | 8/5 M-F w/JLAB Holidays ReBaseline | PROCUREMENT>$50K 69 NO ESCALATION | 159,910 | FENKER H | 1 | 1 | 07-034 | HOWARD F | 08-048 | 09-022 |  | 10-069 | 11-026 | 13-006 |  |  | 4314 | 09-012 | 10-076 | 11-017 | 11-046 | 12-012 | 12-036F | 08-052 |  |  | OPEN OBLIGATION | 24314035 | y | P | OB | YES | 13-015 | PR | OB |  |  |  |  |  |
| 24314P4LOE |  | Dipole- P-4 Contract Mngmnt for Dipole |  | 20d | 2013-09-03 | 2013-09-30 | 9-130M FS+228d | 495d | 0d |  | 8/5 M-F w/JLAB Holidays ReBaseline | MECH ENG [25.8 h]; TRAVEL; MECH DES [6.45 h] | 3,186 | FENKER H | 1 | 1 | 07-034 | HOWARD F | 08-048 | 09-022 |  | 10-069 | 11-026 | 13-006F |  |  |  |  |  |  |  | 12-012 |  |  |  |  | OPEN OBLIGATION | 24314P4LOE |  | E |  |  | 13-015 | PR |  | PE | PE |  |  |  |
| 24314P4TLOE |  | Dipole- P-4 Contract Extra Travel |  | 20d | 2013-09-03 | 2013-09-30 | 24314P4LOE FS-20d | 495d | 0d |  | 8/5 M-F w/JLAB Holidays ReBaseline | TRAVEL | 1,565.81 | FENKER H | 1 | 1 |  | HOWARD F |  |  |  |  |  | 13-006 |  |  |  |  |  |  |  |  |  |  |  |  |  | 24314P4TLOE |  | E |  |  | 13-015 | PR |  | PE | PE |  |  |  |
| 24314110 |  | Planning Package SigmaPhi Phase 2 ( Coil Development, VPI ) |  | 128d | 2013-10-01 | 2014-04-11 | 9-140M | 861d | 923d |  | 8/5 M-F w/JLAB Holidays ReBaseline | PROCUREMENT>$50K 69 NO ESCALATION | 534,000 | FENKER H | 1 | 1 |  | HOWARD F |  |  |  |  |  | 13-006 |  |  | 4314 |  |  |  |  |  |  |  |  |  |  | 24314110 |  | D | EV |  | 13-015 | PR |  |  |  |  |  |  |
| 24314P5LOE |  | Dipole- P-5 Contract Mngmnt for Dipole |  | 247d | 2013-10-01 | 2014-09-30 | 24314P4TLOE | 495d | 0d |  | 8/5 M-F w/JLAB Holidays ReBaseline | MECH ENG [320 h]; TRAVEL | 54,851.4 | FENKER H | 1 | 1 |  | HOWARD F |  |  |  |  |  | 13-006 |  |  |  |  |  |  |  |  |  |  |  |  |  | 24314P5LOE |  | E |  |  | 13-015 | PR |  | PE | PE | 14-001 |  |  |
| 24314047 |  | Dipole Inspect Coil |  | 20d | 2014-03-04 | 2014-03-31 | 24314020 FS-20d | 106d |  |  | 8/5 M-F w/JLAB Holidays ReBaseline | MECH ENG [40 h]; TRAVEL | 7,816.11 | FENKER H | 1 | 1 | 07-034 | HOWARD F | 08-048 | 09-022 |  | 10-069 | 11-026 | 13-006F |  |  | 4314 |  | 10-076 | 11-017 | 11-046 | 12-012 | 12-036F | 08-052 |  |  | NO PROC | 24314047 |  | H |  |  | 13-015 | PR |  | PE | PE | 14-001 |  |  |
| 24314048 |  | Dipole Inspect Cold Mass |  | 20d | 2014-09-17 | 2014-10-14 | 24314027 FS-10d, 2-29M FS-290d | 205d | 143d |  | 8/5 M-F w/JLAB Holidays ReBaseline | TRAVEL; MECH ENG [40 h] | 7,970.16 | FENKER H | 1 | 1 | 07-034 | HOWARD F | 08-048 | 09-022 |  | 10-069 | 11-026 | 13-006 |  |  | 4314 |  | 10-076 | 11-017 | 11-046 | 12-012 | 12-036 | 08-052 |  |  |  | 24314048 |  | H |  |  | 13-015 | PR |  | PE | PE | 14-001 | 12-054 |  |
| 24314P6LOE |  | Dipole- P-6 Contract Mngmnt for Dipole |  | 247d | 2014-10-01 | 2015-10-01 | 24314P5LOE, 24314P4TLOE | 495d | 557d |  | 8/5 M-F w/JLAB Holidays ReBaseline | MECH ENG [320 h]; TRAVEL | 54,851.4 | FENKER H | 1 | 1 |  | HOWARD F |  |  |  |  |  | 13-006 |  |  |  |  |  |  |  |  |  |  |  |  |  | 24314P6LOE |  | E |  |  | 13-015 | PR |  | PE | PE | 14-001 |  |  |
| 24314049 |  | Dipole Witness Final Factory Tests |  | 40d | 2015-02-04 | 2015-03-31 | 2-29M FS-90d, 24314030 FS-40d | 185d | 123d |  | 8/5 M-F w/JLAB Holidays ReBaseline | MECH ENG [40 h]; TRAVEL | 7,970.16 | FENKER H | 1 | 1 | 07-034 | HOWARD F | 08-048 | 09-022 |  | 10-069 | 11-026 | 13-006 |  |  | 4314 |  | 10-076 | 11-017 | 11-046 | 12-012 | 12-036 | 08-052 |  |  |  | 24314049 |  | H |  |  | 13-015 | PR |  | PE | PE | 14-001 |  |  |
| 24314030a |  | Dipole Magnet Shipping |  | 54d | 2015-03-04 | 2015-05-18 | 24314030 FS-20d | 0d |  |  | 8/5 M-F w/JLAB Holidays ReBaseline |  |  | FENKER H | 1 | 1 | 07-034 | HOWARD F | 08-048 | 09-022 |  | 10-069 | 11-026 | 13-006 |  |  | 4314 |  | 10-076 | 11-017 | 11-046 | 12-012 | 12-036 | 08-052 |  |  | NO RESOURCES | 24314030a |  | Z |  |  | 13-015 | PR |  |  |  |  |  |  |
| 24314040 |  | Dipole Drawing Validation |  | 89d | 2015-05-19 | 2015-09-24 | 24314048, 2-29M | 62d | 0d |  | 8/5 M-F w/JLAB Holidays ReBaseline | MECH DES [480 h] | 24,624 | FENKER H | 1 | 1 | 07-034 | HOWARD F | 08-048 | 09-022 | 10-008 | 10-069 | 11-026 | 13-006 |  |  | 4314 |  | 10-076 |  |  |  | 12-036 |  |  |  |  | 24314040 |  | S |  |  | 13-015 | PR |  | PE |  | 14-001 |  | Pat |
| 24314050M |  | Dipole Ready for Installation | milestone | 0d | 2015-05-19 | 2015-05-19 | 2-29M | 0d |  |  | 8/5 M-F w/JLAB Holidays ReBaseline |  |  | FENKER H | 1 | 1 | 07-034 | HOWARD F | 08-048 | 09-022 |  | 10-069 |  | 13-006 |  |  |  | 09-012 | 10-076 | 11-017 | 11-046 | 12-012 | 12-036 |  |  |  |  | 24314050M |  | M |  |  | 13-015 | PR |  |  |  |  |  |  |
| 24314035a |  | Dipole HC Test |  | 5d | 2015-08-26 | 2015-09-01 | 28236000, 28236005 FS-5d, 24368305 | 0d |  |  | 8/5 M-F w/JLAB Holidays ReBaseline | MECH TECH [40 h]; MECH ENG [80 h] | 7,866.4 | FENKER H | 1 | 1 | 07-034 | HOWARD F | 08-048 | 09-022 |  | 10-069 | 11-026 | 13-006 |  |  | 4314 | 09-012 | 10-076 |  | 11-046 | 12-012 | 12-036 | 08-052 |  |  |  | 24314035a |  | H |  |  | 13-015 | PR |  | PE |  | 14-001 | 12-054 |  |
| 24314051M |  | Dipole Contract Complete | milestone | 0d | 2015-09-25 | 2015-09-25 | 24314040, 24314049 | 62d |  |  | 8/5 M-F w/JLAB Holidays ReBaseline |  |  | FENKER H | 1 | 1 | 07-034 | HOWARD F | 08-048 | 09-022 |  | 10-069 |  | 13-006 |  |  |  | 09-012 | 10-076 | 11-017 | 11-046 | 12-012 | 12-036 |  |  |  |  | 24314051M |  | M |  |  | 13-015 | PR |  |  |  |  |  |  |

Notes:
- 14314010: Corrective Actions: 07 Mar 2007, Added This Activity to / Match Fy08-15 Master Schedule. PMC
- 14314045: Corrective Actions: 07 Mar 2007, Added This Activity to Match Fy08-15 Master / Schedule. PMC

| ID | WBS | Activity | Type | Duration | Start | Finish | Predecessors | Total float | Free float | Resources | Cost | RESP - Responsibility | STRT%COMP for CM EVM | FNSH%COMP for CM EVM | CR 07-034 | CAM RESPONSIBLE | CR 08-048 | CR 08-059 | CR 10-069 | CR 10-076 | CR 11-026 | CR 13-006 | CR 11-046 | CR 12-012 | CR 12-036 | CR 09-022 | CR 11-017 | CR 10-008 | CR 11-025 | CR 10-001 | CR 10-063 | CR 10-075 | CR 12-003 | CR 12-054 | 12 GEV MAJOR PROCUREMENT CATAGORY | CR 10-022 | CR 10-057 | CR 10-052 | CR 08-052 | CR 12-055 | CR 12-001 | CR 12-023 | CR 12-053 | CR 12-022 | CR 13-014 |
| --- | --- | --- | --- | --- | --- | --- | --- | --- | --- | --- | --- | --- | --- | --- | --- | --- | --- | --- | --- | --- | --- | --- | --- | --- | --- | --- | --- | --- | --- | --- | --- | --- | --- | --- | --- | --- | --- | --- | --- | --- | --- | --- | --- | --- | --- |
|  | 5 | **1.4.3.1.5 MAGNET COMPONENTS PROCURED BY JLAB** |  |  | 2009-01-02 | 2014-08-25 |  |  |  |  |  |  |  |  |  |  |  |  |  |  |  |  |  |  |  |  |  |  |  |  |  |  |  |  |  |  |  |  |  |  |  |  |  |  |  |
| 14315010 |  | Design Superconductor for Q2/3 and Dipole |  | 20d | 2009-01-02 | 2009-01-30 | 9-090M FS+59d | 1093d | 83d | MECH DES [72 h]; MECH ENG [140 h] | 12,089.88 | FENKER H | 1 | 1 | 07-034 | HOWARD F | 08-048 | 08-059 | 10-069 | 10-076 | 11-026 | 13-006F |  |  |  |  |  |  |  |  |  |  |  |  |  |  |  |  |  |  |  |  |  |  |  |
| 14315042 |  | Bidding Process Iron Yoke for Q2/3 and Dipole |  | 80d | 2009-03-05 | 2009-06-25 | 14315055x | 692d | 628d |  |  | FENKER H | 1 | 1 | 07-034 | HOWARD F | 08-048 |  | 10-069 | 10-076 | 11-026 | 13-006F | 11-046 | 12-012 | 12-036F |  |  |  |  |  |  |  |  |  |  |  |  |  |  |  |  |  |  |  |  |
| 14315050LOE |  | Procurement Oversight |  | 106d | 2009-05-01 | 2009-09-30 | 9-090M FS+142d, 14315010 FS-20d | 1010d | 0d | MECH DES [80 h]; TRAVEL; MECH ENG [240 h] | 25,070.48 | FENKER H | 1 | 1 | 07-034 | HOWARD F | 08-048 |  | 10-069 |  | 11-026 | 13-006F |  |  |  | 09-022 |  |  |  |  |  |  |  |  |  |  |  |  |  |  |  |  |  |  |  |
| 14315022 |  | Bidding Process Cryo Reservoirs for All Mag |  | 50d | 2009-05-26 | 2009-08-04 | 14315050x FS+37d | 346d | 99d |  |  | FENKER H | 1 | 1 | 07-034 | HOWARD F | 08-048 |  | 10-069 | 10-076 | 11-026 |  |  | 12-012 | 12-036F | 09-022 | 11-017 |  |  |  |  |  |  |  |  |  |  |  |  |  |  |  |  |  |  |
| 14315012 |  | Bidding Process Superconductor for Q2/3 and Dipole |  | 40d | 2009-06-10 | 2009-08-05 | 9-090M FS+169d | 300d | 181d |  |  | FENKER H | 1 | 1 | 07-034 | HOWARD F | 08-048 |  | 10-069 | 10-076 | 11-026 |  | 11-046 | 12-012 | 12-036F |  | 11-017 | 10-008 | 11-025 |  |  |  |  |  |  |  |  |  |  |  |  |  |  |  |  |
| 14315030 |  | Design Instruments & Controls for All Mag FY09 |  | 63d | 2009-07-02 | 2009-09-30 | 9-090M FS+185d | 251d | 0d | MECH DES [121.42 h]; MECH ENG [229.09 h] | 19,941.28 | FENKER H | 1 | 1 | 07-034 | HOWARD F | 08-048 |  | 10-069 | 10-076 | 11-026 |  |  | 12-012 | 12-036F | 09-022 |  |  |  | 10-001B | 10-063 |  |  |  |  |  |  |  |  |  |  |  |  |  |  |
| 14315030b |  | Design Instruments & Controls for All Mag FY10 |  | 157d | 2009-10-01 | 2010-05-21 | 14315030 | 251d | 0d | MECH DES [302.58 h]; MECH ENG [570.91 h] | 51,283.14 | FENKER H | 1 | 1 |  | HOWARD F |  |  | 10-069 | 10-076 | 11-026 |  |  | 12-012 | 12-036F |  |  |  |  | 10-001B | 10-063 |  |  |  |  |  |  |  |  |  |  |  |  |  |  |
| 14315050LOEb |  | Procurement Oversight |  | 248d | 2009-10-01 | 2010-09-30 | 14315050LOE | 1010d | 0d | MECH ENG [240 h]; MECH DES [80 h]; TRAVEL | 25,871.42 | FENKER H | 1 | 1 | 07-034 | HOWARD F | 08-048 |  | 10-069 |  | 11-026 | 13-006F |  |  |  | 09-022 |  |  |  |  |  |  |  |  |  |  |  |  |  |  |  |  |  |  |  |
| 14315000 |  | Design DC Pwr Sys for All Mag (IPL) |  | 20d | 2009-12-15 | 2010-01-20 | 9-100M FS+51d | 101d | 0d | MECH ENG [220 h]; MECH DES [120 h] | 19,915.8 | FENKER H | 1 | 1 | 07-034 | HOWARD F | 08-048 |  | 10-069 | 10-076 | 11-026 | 13-006 | 11-046 | 12-012 | 12-036F | 09-022 |  | 10-008 |  |  |  | 10-075 | 12-003 | 12-054F |  |  |  |  |  |  |  |  |  |  |  |
| 14315025 |  | Vend Fab Cryo Reservoirs Receipt of Materials less Electric Cylinders and LVDTs |  | 19d | 2010-01-04 | 2010-01-29 | 9-100M FS+59d, 14315022 | 247d | 0d | PROCUREMENT>$50K 69 NO ESCALATION; PROCUREMENT<$50K 60 NO ESCALATION | 242,300 | FENKER H | 1 | 1 | 07-034 | HOWARD F | 08-048 |  | 10-069 | 10-076 | 11-026 |  |  | 12-012 | 12-036F | 09-022 | 11-017 |  |  |  |  |  |  |  | 4315 | 10-022 |  |  |  |  |  |  |  |  |  |
| 14315026 |  | Vend Fab Cryo Reservoirs Receipt of Electric Cylinders and LVDTs |  | 61d | 2010-01-04 | 2010-03-31 | 14315025 FS-19d | 247d | 0d | PROCUREMENT>$50K 69 NO ESCALATION | 134,500 | FENKER H | 1 | 1 | 07-034 | HOWARD F | 08-048 |  | 10-069 | 10-076 | 11-026 |  |  | 12-012 | 12-036F | 09-022 | 11-017 |  |  |  |  |  |  |  | 4315 | 10-022 |  |  |  |  |  |  |  |  |  |
| 14315027 |  | Vend Fab Cryo Reservoirs CCR#2 & 3 JT Valves and Bayonets Complete |  | 168d | 2010-01-04 | 2010-08-31 | 14315055 FS-125d, 14315026 FS-61d | 247d | 0d | PROCUREMENT>$50K 69 NO ESCALATION | 52,000 | FENKER H | 1 | 1 | 07-034 | HOWARD F | 08-048 |  | 10-069 | 10-076 | 11-026 |  |  | 12-012 | 12-036F | 09-022 | 11-017 |  |  |  |  |  |  |  | 4315 | 10-022 |  |  |  |  |  |  |  |  |  |
| 14315027A |  | Vend Fab Cryo Reservoirs CCR#2 & 3 Complete |  | 247d | 2010-01-04 | 2010-12-30 | 14315027 FS-168d | 247d | 0d | PROCUREMENT>$50K 69 NO ESCALATION | 42,000 | FENKER H | 1 | 1 |  | HOWARD F |  |  | 10-069 | 10-076 | 11-026 |  |  | 12-012 | 12-036F |  | 11-017 |  |  |  |  |  |  |  | 4315 | 10-022 |  |  |  |  |  |  |  |  |  |
| 14315027B |  | Vend Fab Cryo Reservoirs CCR#2 & 3 Approved Acceptance Test/Shipment |  | 267d | 2010-01-04 | 2011-01-31 | 14315027A FS-247d | 247d | 0d | PROCUREMENT>$50K 69 NO ESCALATION | 69,100 | FENKER H | 1 | 1 |  | HOWARD F |  |  | 10-069 | 10-076 | 11-026 |  |  | 12-012 | 12-036F |  | 11-017 |  |  |  |  |  |  |  | 4315 | 10-022 |  |  |  |  |  |  |  |  |  |
| 14315027C |  | Vend Fab Cryo Reservoirs CCR#1 Test and Fabrication Documentation |  | 286d | 2010-01-04 | 2011-02-28 | 14315027B FS-267d | 354d | 0d | PROCUREMENT>$50K 69 NO ESCALATION | 28,000 | FENKER H | 1 | 1 |  | HOWARD F |  |  | 10-069 | 10-076 | 11-026 |  |  | 12-012 | 12-036F |  | 11-017 |  |  |  |  |  |  |  | 4315 | 10-022 |  |  |  |  |  |  |  |  |  |
| 14315027D |  | Vend Fab Cryo Reservoirs CCR#4 5 & 6 JT Valves and Bayonets Complete |  | 168d | 2010-01-04 | 2010-08-31 | 14315027C FS-286d | 354d | 0d | PROCUREMENT>$50K 69 NO ESCALATION | 78,000 | FENKER H | 1 | 1 |  | HOWARD F |  |  | 10-069 | 10-076 | 11-026 |  |  | 12-012 | 12-036F |  | 11-017 |  |  |  |  |  |  |  | 4315 | 10-022 |  |  |  |  |  |  |  |  |  |
| 14315027F |  | Vend Fab Cryo Reservoirs CCR#4 5 & 6 Complete |  | 458d | 2010-01-04 | 2011-10-31 | 14315027D FS-168d | 354d | 0d | PROCUREMENT>$50K 69 NO ESCALATION | 63,000 | FENKER H | 1 | 1 |  | HOWARD F |  |  | 10-069 | 10-076 | 11-026 |  |  | 12-012 | 12-036F |  | 11-017 |  |  |  |  |  |  |  | 4315 | 10-022 |  |  |  |  |  |  |  |  |  |
| 14315027G |  | Vend Fab Cryo Reservoirs CCR#4 5 & 6 Approved Acceptance Test/Shipment |  | 494d | 2010-01-04 | 2011-12-29 | 14315027F FS-458d | 354d | 0d | PROCUREMENT>$50K 69 NO ESCALATION | 101,900 | FENKER H | 1 | 1 |  | HOWARD F |  |  | 10-069 | 10-076 | 11-026 |  |  | 12-012 | 12-036F |  | 11-017 |  |  |  |  |  |  |  | 4315 | 10-022 |  |  |  |  |  |  |  |  |  |
| 14315027H |  | Vend Fab Cryo Reservoirs CCR#4 5 & 6 Test and Fabrication Documentation |  | 515d | 2010-01-04 | 2012-01-31 | 14315027G FS-494d | 354d | 0d | PROCUREMENT>$50K 69 NO ESCALATION | 42,100 | FENKER H | 1 | 1 |  | HOWARD F |  |  | 10-069 | 10-076 | 11-026 |  |  | 12-012 | 12-036F |  | 11-017 |  |  |  |  |  |  |  | 4315 | 10-022 |  |  |  |  |  |  |  |  |  |
| 14315015 |  | Procure and Extrude Copper Stabilizer |  | 162d | 2010-05-03 | 2010-12-21 | 14314000M5 FS-63d, 14315012 | 119d | 0d | PROCUREMENT<$50K 60 NO ESCALATION FY11; PROCUREMENT>$50K 69 NO ESCALATION FY11 | 214,142.24 | FENKER H | 1 | 1 | 07-034 | HOWARD F | 08-048 |  | 10-069 | 10-076 | 11-026 |  | 11-046 | 12-012 | 12-036F |  | 11-017 | 10-008 | 11-025 |  |  |  |  |  | 4315 |  | 10-057 |  |  |  |  |  |  |  |  |
| 14315055 |  | Procure Burnout Resistant Current Leads |  | 20d | 2010-05-03 | 2010-05-28 | 9-100M FS+142d | 269d | 22d | PROCUREMENT<$50K 60; PROCUREMENT>$50K 69 | 95,500 | FENKER H | 1 | 1 |  | HOWARD F |  |  | 10-069 | 10-076 | 11-026 |  |  | 12-012 | 12-036F |  | 11-017 |  |  |  |  |  |  |  |  |  |  | 10-052 |  |  |  |  |  |  |  |
| 14315032 |  | Bidding Process Instruments & Controls for All Mag |  | 5d | 2010-05-24 | 2010-05-28 | 14315030b | 251d | 0d |  |  | FENKER H | 1 | 1 | 07-034 | HOWARD F | 08-048 |  | 10-069 | 10-076 | 11-026 |  |  | 12-012 | 12-036F | 09-022 |  |  |  |  | 10-063 |  |  |  |  |  |  |  |  |  |  |  |  |  |  |
| 14315035 |  | Proc Instruments & Controls for HB and Q1 magnets |  | 130d | 2010-06-01 | 2010-12-03 | 14315032 | 251d | 0d | PROCUREMENT>$50K 69 NO ESCALATION FY11; PROCUREMENT<$50K 60 NO ESCALATION FY11 | 343,919.79 | FENKER H | 1 | 1 | 07-034 | HOWARD F | 08-048 |  | 10-069 | 10-076 | 11-026 |  |  | 12-012 | 12-036F | 09-022 |  |  |  |  | 10-063 |  |  |  | 4315 |  |  |  | 08-052 |  |  |  |  |  |  |
| 14315015A |  | Solder SC Cable to Extrusion |  | 113d | 2010-08-06 | 2011-01-25 | 14315015 FS-95d | 129d | 0d | PROCUREMENT<$50K 60 NO ESCALATION FY11; PROCUREMENT>$50K 69 NO ESCALATION FY11 | 181,696 | FENKER H | 1 | 1 |  | HOWARD F |  |  | 10-069 | 10-076 | 11-026 |  | 11-046 | 12-012 | 12-036F |  | 11-017 |  | 11-025 |  |  |  |  |  | 4315 |  | 10-057 |  |  |  |  |  |  |  |  |
| 14315015B |  | Obtain RRR Measurement of Copper Part A |  | 113d | 2010-08-06 | 2011-01-25 | 14315015 FS-95d | 119d | 0d | PROCUREMENT<$50K 60 NO ESCALATION FY11 | 12,500 | FENKER H | 1 | 1 |  | HOWARD F |  |  | 10-069 | 10-076 | 11-026 |  | 11-046 | 12-012 | 12-036F |  | 11-017 |  | 11-025 |  |  |  |  |  | 4315 |  | 10-057 |  |  | 12-055 |  |  |  |  |  |
| 14315015Ba |  | Obtain RRR Measurement of Copper Part B |  | 113d | 2010-08-06 | 2011-01-25 | 14315015 FS-95d | 119d | 0d | PROCUREMENT<$50K 60 NO ESCALATION FY11 | 12,500 | FENKER H | 1 | 1 |  | HOWARD F |  |  | 10-069 | 10-076 | 11-026 |  | 11-046 | 12-012 | 12-036F |  | 11-017 |  | 11-025 |  |  |  |  |  | 4315 |  | 10-057 |  |  | 12-055 |  |  |  |  |  |
| 14315002 |  | Bidding Process DC Pwr Sys for HB & Q1 Mag |  | 80d | 2010-08-30 | 2010-12-29 | 14315000 FS+154d | 101d | 0d |  |  | FENKER H | 1 | 1 | 07-034 | HOWARD F | 08-048 |  | 10-069 | 10-076 | 11-026 |  | 11-046 | 12-012 | 12-036F | 09-022 |  | 10-008 |  |  |  | 10-075 | 12-003 | 12-054F |  |  |  |  |  |  |  |  |  |  |  |
| 14315003 |  | Bidding Process DC Pwr Sys forQ2/Q3/Dipole Mag |  | 80d | 2010-08-30 | 2010-12-29 | 14315000 FS+154d | 101d | 0d |  |  | FENKER H | 1 | 1 | 07-034 | HOWARD F | 08-048 |  | 10-069 | 10-076 | 11-026 |  | 11-046 | 12-012 | 12-036F | 09-022 |  | 10-008 |  |  |  | 10-075 | 12-003 | 12-054F |  |  |  |  |  |  |  |  |  |  |  |
| 14315027J |  | Vend Fab Cryo Reservoirs CCR#4 5 & 6 Vendor Change Order |  | 1d | 2010-09-01 | 2010-09-01 | 14315027D | 700d | 346d | PROCUREMENT>$50K 69 NO ESCALATION | 21,000 | FENKER H | 1 | 1 |  | HOWARD F |  |  | 10-069 | 10-076 | 11-026 |  |  | 12-012 | 12-036F |  | 11-017 |  |  |  |  |  |  |  | 4315 | 10-022 |  |  |  |  |  |  |  |  |  |
| 14315060 |  | Vend Fab DCPS - Design & Approval |  | 98d | 2010-09-30 | 2011-02-28 | 14315002 FS-58d, 14315003 FS-58d | 101d | 0d | PROCUREMENT<$50K 60 NO ESCALATION; PROCUREMENT>$50K 69 NO ESCALATION | 225,000 | FENKER H | 1 | 1 |  | HOWARD F |  |  |  | 10-076 | 11-026 |  | 11-046 | 12-012 | 12-036F |  |  |  |  |  |  | 10-075 | 12-003 | 12-054F |  |  |  |  |  |  |  |  |  |  |  |
| 14315065 |  | Vend Fab DCPS - Materials in-house to start prod: Items 1&2 |  | 142d | 2010-09-30 | 2011-04-29 | 14315060 FS-98d | 101d | 0d | PROCUREMENT>$50K 69 NO ESCALATION | 159,000 | FENKER H | 1 | 1 |  | HOWARD F |  |  |  | 10-076 | 11-026 |  | 11-046 | 12-012 | 12-036F |  |  |  |  |  |  | 10-075 | 12-003 | 12-054F |  |  |  |  |  |  |  |  |  |  |  |
| 14315070 |  | Vend Fab DCPS - Materials in-house to start prod: Items 3,4,&5 |  | 290d | 2010-09-30 | 2011-11-30 | 14315065 FS-142d | 101d | 0d | PROCUREMENT>$50K 69 NO ESCALATION | 245,000 | FENKER H | 1 | 1 |  | HOWARD F |  |  |  | 10-076 | 11-026 |  | 11-046 | 12-012 | 12-036F |  |  |  |  |  |  | 10-075 | 12-003 | 12-054F |  |  |  |  |  |  |  |  |  |  |  |
| 14315075 |  | Vend Fab DCPS - Shipment of Items 1&2 |  | 347d | 2010-09-30 | 2012-02-29 | 14315070 FS-290d | 101d | 0d | PROCUREMENT>$50K 69 NO ESCALATION | 77,000 | FENKER H | 1 | 1 |  | HOWARD F |  |  |  | 10-076 | 11-026 |  | 11-046 | 12-012 | 12-036F |  |  |  |  |  |  | 10-075 | 12-003 | 12-054F |  |  |  |  |  |  |  |  |  |  |  |
| 14315080 |  | Vend Fab DCPS - Arrival Test of Items 1&2 |  | 412d | 2010-09-30 | 2012-05-31 | 14315075 FS-347d | 101d | 0d | PROCUREMENT>$50K 69 NO ESCALATION | 28,000 | FENKER H | 1 | 1 |  | HOWARD F |  |  |  | 10-076 | 11-026 |  | 11-046 | 12-012 | 12-036F |  |  |  |  |  |  | 10-075 | 12-003 | 12-054F |  |  |  |  |  |  |  |  |  |  |  |
| 14315085 |  | Vend Fab DCPS - Shipment of Items 3,4,&5 |  | 518d | 2010-09-30 | 2012-10-30 | 14315080 FS-412d | 101d | 0d | PROCUREMENT>$50K 69 NO ESCALATION | 117,000 | FENKER H | 1 | 1 |  | HOWARD F |  |  |  | 10-076 | 11-026 |  | 11-046 | 12-012 | 12-036F |  |  |  |  |  |  | 10-075 | 12-003 | 12-054F |  |  |  |  |  |  |  |  |  |  |  |
| 14315090 |  | Vend Fab DCPS - Arrival Test of Items 3,4,&5 |  | 616d | 2010-09-30 | 2013-03-29 | 14315085 FS-518d | 683d | 0d | PROCUREMENT>$50K 69 NO ESCALATION | 53,320 | FENKER H | 1 | 1 |  | HOWARD F |  |  |  | 10-076 | 11-026 |  |  |  |  |  |  |  |  |  |  | 10-075 |  |  |  |  |  |  |  |  |  |  |  |  |  |
| 14315095 |  | Vend Fab DCPS -Delivery of Spare Parts & Maintenance Inventory |  | 616d | 2010-09-30 | 2013-03-29 | 14315090 FS-616d | 683d |  | PROCUREMENT>$50K 69 NO ESCALATION | 17,762 | FENKER H | 1 | 1 |  | HOWARD F |  |  |  | 10-076 | 11-026 |  |  |  |  |  |  |  |  |  |  | 10-075 |  |  |  |  |  |  |  |  |  |  |  |  |  |
| 14315050LOEc |  | Procurement Oversight |  | 247d | 2010-10-01 | 2011-09-29 | 14315050LOEb | 1010d | 0d | MECH DES [80 h]; TRAVEL; MECH ENG [240 h] | 26,696.32 | FENKER H | 1 | 1 | 07-034 | HOWARD F | 08-048 |  | 10-069 |  | 11-026 | 13-006F |  |  |  | 09-022 |  |  |  |  |  |  |  |  |  |  |  |  |  |  |  |  |  |  |  |
| 14315038 |  | Assemble & Test Instruments & Controls Phase 1 (FY10) |  | 100d | 2010-12-06 | 2011-05-04 | 14315035 | 251d | 0d | ELEC TECH [800 h]; MECH ENG [520 h] | 69,550 | FENKER H | 1 | 1 | 07-034 | HOWARD F | 08-048 |  | 10-069 | 10-076 | 11-026 |  |  | 12-012 | 12-036F | 09-022 |  |  |  |  | 10-063 |  |  |  |  |  |  |  |  |  |  |  |  |  |  |
| 14315016 |  | Inspect & Ship Superconductor for Q2/3 and Dipole to ReRolling Facility |  | 30d | 2011-01-26 | 2011-03-09 | 14315015Ba, 14315015B | 119d | 0d | MECH ENG [200 h]; MECH DES [240 h]; SUPPLIES & MATERIALS | 37,265.39 | FENKER H | 1 | 1 | 07-034 | HOWARD F | 08-048 |  | 10-069 | 10-076 | 11-026 |  | 11-046 | 12-012 | 12-036F |  | 11-017 | 10-008 | 11-025 |  |  |  |  |  |  |  |  |  |  |  |  |  |  |  |  |
| 14315028 |  | Inspect & Ship Cryo Reservoirs for HB & Q1 magnets |  | 63d | 2011-02-01 | 2011-04-29 | 14315025, 14315027B | 247d | 0d | MECH ENG [360 h]; MECH DES [160 h]; MECH TECH [320 h]; SUPPLIES & MATERIALS | 54,783.89 | FENKER H | 1 | 1 | 07-034 | HOWARD F | 08-048 |  | 10-069 |  | 11-026 |  | 11-046 | 12-012 | 12-036F | 09-022 |  |  |  |  | 10-063 |  | 12-003 |  |  | 10-022 |  |  |  |  |  |  |  |  |  |
| 14315031M |  | Q1 Magnet Vendor Receipt of Cryoresevoir | milestone | 0d | 2011-04-29 | 2011-04-29 | 14315028 | 247d | 227d |  |  | FENKER H | 1 | 1 | 07-034 | HOWARD F | 08-048 |  | 10-069 |  | 11-026 |  | 11-046 | 12-012 | 12-036F | 09-022 |  |  |  |  | 10-063 |  | 12-003 |  |  | 10-022 |  |  |  |  |  |  |  |  |  |
| 14315015A5 |  | Completion of Solder SC Cable to Extrusion Part A |  | 10d | 2011-05-02 | 2011-05-13 | 14315015A FS+67d | 129d | 10d | PROCUREMENT<$50K 60; PROCUREMENT>$50K 69 | 92,000 | FENKER H | 1 | 1 |  | HOWARD F |  |  | 10-069 | 10-076 | 11-026 |  | 11-046 | 12-012 | 12-036F |  | 11-017 |  | 11-025 |  |  |  |  |  | 4315 |  | 10-057 |  |  | 12-055 |  |  |  |  |  |
| 14315015A5a |  | Completion of Solder SC Cable to Extrusion Part B |  | 10d | 2011-05-02 | 2011-05-13 | 14315015A FS+67d | 129d | 10d | PROCUREMENT>$50K 69 | 15,000 | FENKER H | 1 | 1 |  | HOWARD F |  |  | 10-069 | 10-076 | 11-026 |  | 11-046 | 12-012 | 12-036F |  | 11-017 |  | 11-025 |  |  |  |  |  | 4315 |  | 10-057 |  |  | 12-055 |  |  |  |  |  |
| 14315018 |  | ReRoll Superconductor Prototype Run |  | 20d | 2011-05-02 | 2011-05-27 | 14315016 FS+37d | 119d | 0d | PROCUREMENT<$50K 60 | 15,000 | FENKER H | 1 | 1 | 07-034 | HOWARD F | 08-048 |  | 10-069 | 10-076 | 11-026 |  | 11-046 | 12-012 | 12-036F |  | 11-017 | 10-008 | 11-025 |  |  |  |  |  |  |  |  |  |  |  |  |  |  |  |  |
| 14315037a |  | Assemble & Test Instruments & Controls Phase 2 (FY11) |  | 100d | 2011-05-05 | 2011-09-26 | 14315038 | 251d | 134d | ELEC TECH [800 h]; MECH ENG [520 h] | 69,550 | FENKER H | 1 | 1 | 07-034 | HOWARD F | 08-048 |  | 10-069 | 10-076 | 11-026 |  |  | 12-012 | 12-036F | 09-022 |  |  |  |  | 10-063 |  |  |  |  |  |  |  |  |  |  |  |  |  |  |
| 14315020 |  | Ship Superconductor for Q2/3 and Dipole to Magnet Vendor |  | 20d | 2011-05-31 | 2011-06-27 | 14315015A5a, 14315018, 14315019 FS-200d, 14315015A5, 14315019B FS-473d | 119d | 0d | SUPPLIES & MATERIALS | 12,500 | FENKER H | 1 | 1 | 07-034 | HOWARD F | 08-048 |  | 10-069 | 10-076 | 11-026 |  | 11-046 | 12-012 | 12-036F |  | 11-017 | 10-008 | 11-025 |  |  |  |  |  |  |  |  |  |  |  |  |  |  |  |  |
| 14315050LOEd |  | Procurement Oversight FY11 |  | 1d | 2011-09-30 | 2011-09-30 | 14315050LOEc | 1010d | 0d | TRAVEL; MECH ENG [0.97 h]; MECH DES [0.32 h] | 107.79 | FENKER H | 1 | 1 | 07-034 | HOWARD F | 08-048 |  | 10-069 |  | 11-026 | 13-006F |  |  |  | 09-022 |  |  |  |  |  |  |  |  |  |  |  |  |  |  | 12-001 |  |  |  |  |
| 14315050LOEf |  | Procurement Oversight FY12 |  | 246d | 2011-10-03 | 2012-09-27 | 14315050LOEd | 1010d | 0d | TRAVEL; MECH ENG [239.03 h]; MECH DES [79.68 h] | 27,437.35 | FENKER H | 1 | 1 | 07-034 | HOWARD F | 08-048 |  | 10-069 |  | 11-026 | 13-006F |  |  |  | 09-022 |  |  |  |  |  |  |  |  |  |  |  |  |  |  | 12-001 |  |  |  |  |
| 14315029 |  | Inspect & Ship Cryo Reservoirs for Q2/3 & Dipole magnets |  | 40d | 2011-12-30 | 2012-02-28 | 14315027, 14315027G, 14315027H FS-21d, 14315026, 14315027J FS-21d | 354d | 0d | SUPPLIES & MATERIALS; MECH ENG [480 h]; MECH DES [640 h] | 82,036.49 | FENKER H | 1 | 1 | 07-034 | HOWARD F | 08-048 |  | 10-069 | 10-076 | 11-026 |  |  | 12-012 | 12-036F | 09-022 | 11-017 |  |  |  |  |  |  |  |  | 10-022 |  |  |  |  |  |  |  |  |  |
| 14315019 |  | ReDraw Superconductor Production Run |  | 30d | 2012-01-04 | 2012-02-15 | 9-120M FS+59d, 14315018 | 143d | 24d | PROCUREMENT<$50K 60; PROCUREMENT>$50K 69; TRAVEL; MECH ENG [40 h] | 106,204.8 | FENKER H | 1 | 1 | 07-034 | HOWARD F | 08-048 |  | 10-069 | 10-076 | 11-026 |  | 11-046 | 12-012 | 12-036F |  | 11-017 | 10-008 | 11-025 |  |  |  |  |  |  |  |  |  |  |  |  |  |  |  |  |
| 14315043 |  | Dipole Top and Bottom Plates |  | 120d | 2012-01-12 | 2012-07-03 | 9-120M FS+65d | 310d |  | PROCUREMENT<$50K 60; PROCUREMENT>$50K 69 | 190,000 | FENKER H | 1 | 1 | 07-034 | HOWARD F | 08-048 |  | 10-069 |  | 11-026 |  |  | 12-012 | 12-036F | 09-022 |  |  |  |  |  |  |  |  | 4315 |  |  |  | 08-052 |  |  |  |  |  |  |
| 14315045 |  | Vend Fab Yoke Steel Planning for Dipole, Q2, Q3 Delivered & Accepted |  | 55d | 2012-01-12 | 2012-03-30 | 9-120M FS+65d, 14315042 | 64d | 0d | PROCUREMENT<$50K 60 NO ESCALATION | 10,000 | FENKER H | 1 | 1 |  | HOWARD F |  |  |  |  |  | 13-006F |  |  | 12-036F |  |  |  |  |  |  |  |  |  | 4315 |  |  |  |  |  |  | 12-023 |  |  |  |
| 14315045A |  | Vend Fab Yoke Steel Receipt of Steel Material Inspected |  | 98d | 2012-01-12 | 2012-05-31 | 14315045 FS-55d | 64d | 0d | PROCUREMENT<$50K 60 NO ESCALATION; PROCUREMENT>$50K 69 NO ESCALATION | 262,000 | FENKER H | 1 | 1 |  | HOWARD F |  |  |  |  |  | 13-006F |  |  | 12-036F |  |  |  |  |  |  |  |  |  | 4315 |  |  |  |  |  |  | 12-023 |  |  |  |
| 14315045B |  | Vend Fab Yoke Steel 1st Article: 1st Dipole/Yoke/Casting Inspt/Accept |  | 118d | 2012-01-12 | 2012-06-29 | 14315045A FS-98d | 64d | 0d | PROCUREMENT>$50K 69 NO ESCALATION | 150,000 | FENKER H | 1 | 1 |  | HOWARD F |  |  |  |  |  | 13-006F |  |  | 12-036F |  |  |  |  |  |  |  |  |  | 4315 |  |  |  |  |  |  | 12-023 |  |  |  |
| 14315045C |  | Vend Fab Yoke Steel SHMS Dipole Casting/ Annealing Comp. Casting Delv/Accept |  | 163d | 2012-01-12 | 2012-08-31 | 14315045B FS-118d | 149d | 0d | PROCUREMENT>$50K 69 NO ESCALATION | 558,000 | FENKER H | 1 | 1 |  | HOWARD F |  |  |  |  |  |  |  |  | 12-036F |  |  |  |  |  |  |  |  |  | 4315 |  |  |  |  |  |  | 12-023 |  |  |  |
| 14315045D |  | Vend Fab Yoke Steel SHMS Q3 Cast/Annel Comp. Cast Deliv.Accept |  | 205d | 2012-01-12 | 2012-10-31 | 14315045C FS-163d | 149d | 0d | PROCUREMENT>$50K 69 NO ESCALATION | 190,000 | FENKER H | 1 | 1 |  | HOWARD F |  |  |  |  |  |  |  |  | 12-036F |  |  |  |  |  |  |  |  |  | 4315 |  |  |  |  |  |  | 12-023 |  |  |  |
| 14315045F |  | Vend Fab Yoke Steel SHMS Q2 Cast/Annel Comp. Cast Deliv/Accept |  | 281d | 2012-01-12 | 2013-02-28 | 14315045D FS-205d, 14315044LOE FS-281d, 14315044LOEa FS-281d | 149d |  | PROCUREMENT>$50K 69 NO ESCALATION | 128,000 | FENKER H | 1 | 1 |  | HOWARD F |  |  |  |  |  |  |  |  | 12-036F |  |  |  |  |  |  |  |  |  | 4315 |  |  |  |  |  |  | 12-023 |  |  |  |
| 14315044LOE |  | Travel Expenses to Yoke Steel Casting Vendor FY12 |  | 169d | 2012-02-01 | 2012-09-28 | 14315045 FS-42d | 149d | 0d | TRAVEL | 31,529.85 | FENKER H | 1 | 1 |  | HOWARD F |  |  |  |  |  |  |  |  | 12-036F |  |  |  |  |  |  |  |  |  |  |  |  |  |  |  |  | 12-023 | 12-053 |  |  |
| 14315046a |  | Vend Fab Yoke supports and cylinders |  | 120d | 2012-02-03 | 2012-07-24 | 9-120M FS+80d, 14315042 | 235d | 0d | PROCUREMENT>$50K 69; PROCUREMENT<$50K 60 | 108,349.5 | FENKER H | 1 | 1 | 07-034 | HOWARD F | 08-048 |  | 10-069 | 10-076 | 11-026 | 13-006F | 11-046 | 12-012 | 12-036F |  |  |  | 11-025 |  |  |  |  |  | 4315 |  |  |  | 08-052 |  |  |  |  |  |  |
| 14315036 |  | Proc Instruments & Controls for Q2/3 and Dipole magnets Part A |  | 130d | 2012-03-05 | 2012-09-05 | 9-120M FS+100d, 14315032 | 117d | 0d | PROCUREMENT>$50K 69; PROCUREMENT<$50K 60 | 133,000 | FENKER H | 1 | 1 | 07-034 | HOWARD F | 08-048 |  | 10-069 | 10-076 | 11-026 |  |  | 12-012 | 12-036F | 09-022 |  |  |  |  |  |  |  |  | 4315 |  |  |  | 08-052 |  |  |  |  | 12-022 |  |
| 14315037 |  | Assemble & Test Instruments & Controls Phase 3 FY12 |  | 117d | 2012-04-16 | 2012-09-28 | 14315037a, 14315036 FS-100d | 117d | 0d | MECH ENG [754.84 h]; ELEC TECH [735.97 h]; ELEC ENG [75.48 h]; MECH DES [301.94 h]; MECH TECH [226.45 h] | 115,341.5 | FENKER H | 1 | 1 | 07-034 | HOWARD F | 08-048 |  | 10-069 | 10-076 | 11-026 |  |  | 12-012 | 12-036F | 09-022 |  |  |  |  |  |  |  |  |  |  |  |  |  |  |  |  | 12-053 |  |  |
| 14315046 |  | Large Magnet Yoke Machining |  | 238d | 2012-07-16 | 2013-06-28 | 14315045B FS+10d, 9-120M FS+45d, 14315042 | 64d |  | PROCUREMENT<$50K 60 NO ESCALATION FY13; PROCUREMENT>$50K 69 NO ESCALATION FY13 | 480,000 | FENKER H | 1 | 1 | 07-034 | HOWARD F | 08-048 |  | 10-069 | 10-076 | 11-026 | 13-006F | 11-046 | 12-012 | 12-036 |  |  |  |  |  |  |  |  |  | 4315 |  |  |  | 08-052 |  |  |  |  |  |  |
| 14315046b |  | Procure Yoke Hardware |  | 60d | 2012-07-25 | 2012-10-17 | 14315046a | 235d |  | PROCUREMENT<$50K 60 NO ESCALATION FY13 | 15,000 | FENKER H | 1 | 1 | 07-034 | HOWARD F | 08-048 |  | 10-069 | 10-076 | 11-026 | 13-006F | 11-046 | 12-012 | 12-036F |  |  |  | 11-025 |  |  |  |  |  | 4315 |  |  |  | 08-052 |  |  |  |  |  |  |
| 14315037b |  | Assemble & Test Instruments & Controls Phase 3 FY13 |  | 131d | 2012-10-01 | 2013-04-15 | 14315037 | 117d |  | MECH ENG [845.16 h]; ELEC TECH [824.03 h]; ELEC ENG [84.52 h]; MECH DES [338.06 h]; MECH TECH [253.55 h] | 133,268.77 | FENKER H | 1 | 1 | 07-034 | HOWARD F | 08-048 |  | 10-069 | 10-076 | 11-026 |  |  | 12-012 | 12-036F | 09-022 |  |  |  |  |  |  |  |  |  |  |  |  |  |  |  |  | 12-053 |  |  |
| 14315044LOEa |  | Travel Expenses to Yoke Steel Casting Vendor FY13 |  | 99d | 2012-10-01 | 2013-02-28 | 14315044LOE, 14315045 FS-42d | 149d | 0d | TRAVEL | 19,059.35 | FENKER H | 1 | 1 |  | HOWARD F |  |  |  |  |  |  |  |  | 12-036F |  |  |  |  |  |  |  |  |  |  |  |  |  |  |  |  | 12-023 | 12-053 |  |  |
| 14315019A |  | Dimensional Inspection of Soldered Conductor at Vendor |  | 80d | 2013-01-02 | 2013-04-25 | 9-130M FS+59d | 119d | 0d | MECH ENG [240 h]; MECH DES [480 h] | 41,227.2 | FENKER H | 1 | 1 |  | HOWARD F |  |  |  |  |  | 13-006 |  |  |  |  |  |  |  |  |  |  |  |  |  |  |  |  |  |  |  |  |  |  |  |
| 14315019B |  | Materials to support Conductor Inspection at Vendor |  | 80d | 2013-01-02 | 2013-04-25 | 14315019A FS-80d | 119d | 0d | PROCUREMENT<$50K 60 | 25,000 | FENKER H | 1 | 1 |  | HOWARD F |  |  |  |  |  | 13-006 |  |  |  |  |  |  |  |  |  |  |  |  |  |  |  |  |  |  |  |  |  |  |  |
| 14315050LOEg |  | Procurement Oversight FY13 |  | 169d | 2013-01-02 | 2013-08-30 | 14315050LOEf FS+60d | 1010d | 1073d | MECH ENG [214.6 h]; MECH DES [71.53 h] | 19,084.82 | FENKER H | 1 | 1 |  | HOWARD F |  |  |  |  |  | 13-006 |  |  |  |  |  |  |  |  |  |  |  |  |  |  |  |  |  |  |  |  |  |  | 13-014 |

Notes:
- 14315000: Explanation: IPL from 6 GeV XXXX

| ID | WBS | Activity | Type | Duration | Start | Finish | Predecessors | Total float | Free float | Calendar | Resources | Cost | RESP - Responsibility | STRT%COMP for CM EVM | FNSH%COMP for CM EVM | CAM RESPONSIBLE | CR 13-006 | CR 13-014 | ReBaseline Actuals Adjustment | Original Activity ID Rebaseline | Over Under Fixed | EVMS Reporting Codes | 12 GEV MAJOR PROCUREMENT CATAGORY | CR 10-057 | CR 10-069 | CR 10-076 | CR 11-017 | CR 11-025 | CR 11-026 | CR 11-046 | CR 12-012 | CR 12-036 | CR 12-055 | BOE Procurement | CR 13-015 | Post Rebaseline | Obligated Prior to Rebaseline | CR 07-034 | CR 08-048 | CR 08-052 | Activities with Steps | CR 09-022 | CR 12-022 | BOE NOTES | Pre Rebaseline Remaining Budget | CR 12-053 | BOE Labor | Previously In Progress | CR 10-075 | CR 12-003 | CR 12-054 | CR 14-001 | Inter Project Link (IPL) | BOE Adder | Milestone Level | CR 07-024 | CR 08-016 | CR 09-012 |
| --- | --- | --- | --- | --- | --- | --- | --- | --- | --- | --- | --- | --- | --- | --- | --- | --- | --- | --- | --- | --- | --- | --- | --- | --- | --- | --- | --- | --- | --- | --- | --- | --- | --- | --- | --- | --- | --- | --- | --- | --- | --- | --- | --- | --- | --- | --- | --- | --- | --- | --- | --- | --- | --- | --- | --- | --- | --- | --- |
| 14315100 |  | Install Moeller Quad #2 (6GEV) |  | 1d | 2013-06-27 | 2013-06-27 | 14351010, 14315020 | 65d |  |  |  |  | FENKER H | 1 | 1 | HOWARD F | 13-006 |  |  |  |  |  |  |  |  |  |  |  |  |  |  |  |  |  |  |  |  |  |  |  |  |  |  |  |  |  |  |  |  |  |  |  |  |  |  |  |  |  |
| 14315105 |  | Re-Baseline Actuals Adjustment |  | 1d | 2013-08-30 | 2013-08-30 | 9-130M FS+227d | 20d |  |  | PROCUREMENT>$50K 69 NO ESCALATION | -10,617.18 | FENKER H | 1 | 1 | HOWARD F |  | 13-014 | ADJ |  |  |  |  |  |  |  |  |  |  |  |  |  |  |  |  |  |  |  |  |  |  |  |  |  |  |  |  |  |  |  |  |  |  |  |  |  |  |  |
| 24315015Ba |  | Obtain Short-Sample SC Measurements |  | 98d | 2013-09-03 | 2014-01-31 | 9-130M FS+228d | 473d |  | 8/5 M-F w/JLAB Holidays ReBaseline | PROCUREMENT<$50K 60 NO ESCALATION FY14 | 15,278.28 | FENKER H | 1 | 1 | HOWARD F | 13-006F |  |  | 24315015Ba | y | D | 4315 | 10-057 | 10-069 | 10-076 | 11-017 | 11-025 | 11-026 | 11-046 | 12-012 | 12-036F | 12-055 | PE | 13-015 | PR | OB |  |  |  |  |  |  |  |  |  |  |  |  |  |  |  |  |  |  |  |  |  |
| 24315015Bb |  | Obtain RRR Measurement of Copper Part B FY13 |  | 20d | 2013-09-03 | 2013-09-30 | 9-130M FS+228d | 527d | 0d | 8/5 M-F w/JLAB Holidays ReBaseline | ELEC TECH [36.36 h] | 1,655.83 | FENKER H | 1 | 1 | HOWARD F | 13-006F |  |  | 24315015Ba |  | D | 4315 | 10-057 | 10-069 | 10-076 | 11-017 | 11-025 | 11-026 | 11-046 | 12-012 | 12-036F | 12-055 | PE | 13-015 | PR |  |  |  |  |  |  |  |  |  |  |  |  |  |  |  |  |  |  |  |  |  |  |
| 24315036a5 |  | Proc Instruments & Controls for Q2/3 and Dipole magnets Part B |  | 98d | 2013-09-03 | 2014-01-31 | 9-130M FS+228d | 287d | 42d | 8/5 M-F w/JLAB Holidays ReBaseline | PROCUREMENT<$50K 60 NO ESCALATION FY14 | 15,000 | FENKER H | 1 | 1 | HOWARD F | 13-006 |  |  | 24315036a5 | y | S | 4315 |  | 10-069 | 10-076 |  |  | 11-026 |  | 12-012 | 12-036F |  | PE | 13-015 | PR | OB | 07-034 | 08-048 | 08-052 | ST | 09-022 | 12-022 |  |  |  |  |  |  |  |  |  |  |  |  |  |  |  |
| 24315037b |  | Assemble & Test Instruments & Controls Phase 3 FY13 |  | 20d | 2013-09-03 | 2013-09-30 | 9-130M FS+228d | 245d | 0d | 8/5 M-F w/JLAB Holidays ReBaseline | MECH ENG [173.04 h]; MECH DES [33.76 h]; MECH TECH [25.32 h] | 15,361.11 | FENKER H | 1 | 1 | HOWARD F | 13-006F |  |  | 24315037b |  | S |  |  | 10-069 | 10-076 |  |  | 11-026 |  | 12-012 | 12-036F |  |  | 13-015 | PR |  | 07-034 | 08-048 |  | ST | 09-022 |  | OPEN OBLIGATION | 215897.7 | 12-053 | PE | Review |  |  |  |  |  |  |  |  |  |  |
| 24315050LOEg |  | Procurement Oversight FY13 |  | 20d | 2013-09-03 | 2013-09-30 | 9-130M FS+228d | 989d | 1051d | 8/5 M-F w/JLAB Holidays ReBaseline | MECH ENG [25.39 h]; MECH DES [8.46 h] | 2,258.38 | FENKER H | 1 | 1 | HOWARD F | 13-006 |  |  | 24315050LOEg |  | E |  |  |  |  |  |  |  |  |  |  |  |  | 13-015 | PR |  |  |  |  |  |  |  |  |  |  | PE |  |  |  |  |  |  |  |  |  |  |  |
| 24315080 |  | Vend Fab DCPS - Arrival Test of Items 1&2 |  | 62d | 2013-09-03 | 2013-11-27 | 9-130M FS+228d | 509d | 0d | 8/5 M-F w/JLAB Holidays ReBaseline | PROCUREMENT>$50K 69 NO ESCALATION | 14,000 | FENKER H | 1 | 1 | HOWARD F | 13-006F |  |  | 24315080 | y | D |  |  |  | 10-076 |  |  | 11-026 | 11-046 | 12-012 | 12-036F |  | OB | 13-015 | PR | OB |  |  |  |  |  |  | OPEN OBLIGATION |  |  |  |  | 10-075 | 12-003 | 12-054F |  |  |  |  |  |  |  |
| 24315090 |  | Vend Fab DCPS - Arrival Test of Items 3,4,&5 |  | 62d | 2013-09-03 | 2013-11-27 | 24315080 FS-62d | 509d |  | 8/5 M-F w/JLAB Holidays ReBaseline | PROCUREMENT>$50K 69 NO ESCALATION | 26,660 | FENKER H | 1 | 1 | HOWARD F |  |  |  | 24315090 | y | D |  |  |  | 10-076 |  |  | 11-026 |  |  |  |  | OB | 13-015 | PR | OB |  |  |  |  |  |  | OPEN OBLIGATION |  |  |  |  | 10-075 |  |  |  |  |  |  |  |  |  |
| 24315015Bba |  | Obtain RRR Measurement of Copper Part B FY14 |  | 24d | 2013-10-01 | 2013-11-01 | 9-130M FS+228d, 24315015Bb | 527d |  | 8/5 M-F w/JLAB Holidays ReBaseline | ELEC TECH [43.64 h] | 2,050.64 | FENKER H | 1 | 1 | HOWARD F | 13-006F |  |  | 24315015Ba |  | D | 4315 | 10-057 | 10-069 | 10-076 | 11-017 | 11-025 | 11-026 | 11-046 | 12-012 | 12-036F | 12-055 | PE | 13-015 | PR |  |  |  |  |  |  |  |  |  |  |  |  |  |  |  | 14-001 |  |  |  |  |  |  |
| 24315037ba |  | Assemble & Test Instruments & Controls Phase 3 FY14 |  | 107d | 2013-10-01 | 2014-03-13 | 9-130M FS+228d, 24315037b | 245d | 0d | 8/5 M-F w/JLAB Holidays ReBaseline | MECH ENG [925.76 h]; MECH DES [180.64 h]; MECH TECH [135.48 h] | 84,803.69 | FENKER H | 1 | 1 | HOWARD F | 13-006F |  |  | 24315037b |  | S |  |  | 10-069 | 10-076 |  |  | 11-026 |  | 12-012 | 12-036F |  |  | 13-015 | PR |  | 07-034 | 08-048 |  | ST | 09-022 |  | OPEN OBLIGATION | 215897.7 | 12-053 | PE | Review |  |  |  | 14-001 |  |  |  |  |  |  |
| 24315007 |  | Test & Integrate DC Pwr Sys for all magnets |  | 60d | 2014-06-02 | 2014-08-25 | 24368265, 24368135, 9-140M | 331d |  | 8/5 M-F w/JLAB Holidays ReBaseline | ELEC TECH [340 h]; ELEC ENG [340 h] | 41,520.8 | FENKER H | 1 | 1 | HOWARD F | 13-006F |  |  | 24315007 |  | S |  |  | 10-069 | 10-076 |  |  | 11-026 |  | 12-012 | 12-036F |  |  | 13-015 | PR |  | 07-034 | 08-048 | 08-052 |  | 09-022 |  |  |  |  | PE |  |  |  | 12-054 | 14-001 | IPL |  |  |  |  |  |
|  | 6 | **1.4.3.1.6 HALL C SPARE COILS** |  |  | 2014-10-01 | 2015-12-01 |  |  |  |  |  |  |  |  |  |  |  |  |  |  |  |  |  |  |  |  |  |  |  |  |  |  |  |  |  |  |  |  |  |  |  |  |  |  |  |  |  |  |  |  |  |  |  |  |  |  |  |  |
|  | 1 | **1.4.3.1.6.1 CONSTRUCTION HALL C SPARE COILS** |  |  | 2014-10-01 | 2015-12-01 |  |  |  |  |  |  |  |  |  |  |  |  |  |  |  |  |  |  |  |  |  |  |  |  |  |  |  |  |  |  |  |  |  |  |  |  |  |  |  |  |  |  |  |  |  |  |  |  |  |  |  |  |
| 243161000 |  | Vendor wind Spare Q2/Q3 Coil |  | 97d | 2014-10-01 | 2015-02-27 | 24313017 FS-141d, 9-155M | 23d | 22d | 8/5 M-F w/JLAB Holidays ReBaseline | PROCUREMENT>$50K 69; PROCUREMENT<$50K 60 | 206,380 | FENKER H | 1 | 1 | HOWARD F | 13-006 |  |  | 24313019b |  | P | 4313 |  |  |  | 11-017 |  | 11-026 |  |  | 12-036F |  | OB | 13-015 | PR |  |  |  |  |  |  |  | OPEN OBLIGATION |  |  |  |  |  |  |  | 14-001 |  | YES |  |  |  |  |
| 243161005 |  | Vendor Prepare Tooling to wind Spare Dipole Coil |  | 15d | 2014-10-01 | 2014-10-21 | 9-155M, 24313017 FS-141d | 1d | 0d | 8/5 M-F w/JLAB Holidays ReBaseline | PROCUREMENT>$50K 69 | 25,797.5 | FENKER H | 1 | 1 | HOWARD F | 13-006 |  |  | 24313019b |  | P | 4313 |  |  |  | 11-017 |  | 11-026 |  |  | 12-036F |  | OB | 13-015 | PR |  |  |  |  |  |  |  | OPEN OBLIGATION |  |  |  |  |  |  |  | 14-001 |  | YES |  |  |  |  |
| 243161030LOE |  | Oversight of Spare Coil Winding |  | 119d | 2014-10-01 | 2015-03-31 | 9-155M | 233d | 149d | 8/5 M-F w/JLAB Holidays ReBaseline | TRAVEL; MECH ENG [952 h] | 96,883.34 | FENKER H | 1 | 1 | HOWARD F | 13-006 |  |  | 24313019b |  | P | 4313 |  |  |  | 11-017 |  | 11-026 |  |  | 12-036F |  | OB | 13-015 | PR |  |  |  |  |  |  |  | OPEN OBLIGATION |  |  |  |  |  |  |  | 14-001 |  | YES |  |  |  |  |
| 243161010 |  | Vendor wind Spare Dipole Coil |  | 104d | 2014-10-22 | 2015-03-31 | 243161005 | 1d | 0d | 8/5 M-F w/JLAB Holidays ReBaseline | PROCUREMENT>$50K 69 | 206,380 | FENKER H | 1 | 1 | HOWARD F | 13-006 |  |  | 24313019b |  | P | 4313 |  |  |  | 11-017 |  | 11-026 |  |  | 12-036F |  | OB | 13-015 | PR |  |  |  |  |  |  |  | OPEN OBLIGATION |  |  |  |  |  |  |  | 14-001 |  | YES |  |  |  |  |
| 243161015 |  | Vendor storage of Spare Coils |  | 149d | 2015-04-01 | 2015-10-30 | 243161000, 243161010 | 1d | 0d | 8/5 M-F w/JLAB Holidays ReBaseline | PROCUREMENT>$50K 69 | 20,638 | FENKER H | 1 | 1 | HOWARD F | 13-006 |  |  | 24313019b |  | P | 4313 |  |  |  | 11-017 |  | 11-026 |  |  | 12-036F |  | OB | 13-015 | PR |  |  |  |  |  |  |  | OPEN OBLIGATION |  |  |  |  |  |  |  | 14-001 |  | YES |  |  |  |  |
| 243161020 |  | Vendor ship spare coils to JLab |  | 20d | 2015-11-02 | 2015-12-01 | 243161030LOE, 243161015 | 84d | 41d | 8/5 M-F w/JLAB Holidays ReBaseline | PROCUREMENT>$50K 69 | 25,797.5 | FENKER H | 1 | 1 | HOWARD F | 13-006 |  |  | 24313019b |  | P | 4313 |  |  |  | 11-017 |  | 11-026 |  |  | 12-036F |  | OB | 13-015 | PR |  |  |  |  |  |  |  | OPEN OBLIGATION |  |  |  |  |  |  |  | 14-001 |  | YES |  |  |  |  |
|  | 2 | **1.4.3.2 DETECTOR** |  |  | 2009-10-01 | 2014-09-03 |  |  |  |  |  |  |  |  |  |  |  |  |  |  |  |  |  |  |  |  |  |  |  |  |  |  |  |  |  |  |  |  |  |  |  |  |  |  |  |  |  |  |  |  |  |  |  |  |  |  |  |  |
|  | 1 | **1.4.3.2.1 WIRE CHAMBERS** |  |  | 2009-10-01 | 2014-09-03 |  |  |  |  |  |  |  |  |  |  |  |  |  |  |  |  |  |  |  |  |  |  |  |  |  |  |  |  |  |  |  |  |  |  |  |  |  |  |  |  |  |  |  |  |  |  |  |  |  |  |  |  |
| 14321000M |  | Award Contract for Wire Chambs | milestone | 0d | 2009-10-01 | 2009-10-01 | 12232015, 9-100M | 249d | 0d |  |  |  | FENKER H | 1 | 1 | HOWARD F |  |  |  |  |  |  |  |  | 10-069 |  |  |  | 11-026 | 11-046 | 12-012 |  |  |  |  |  |  |  |  |  |  | 09-022 |  |  |  |  |  |  |  |  |  |  |  |  | 6 |  |  |  |
| 14321005 |  | Fab Wire Chambers at University |  | 494d | 2009-10-01 | 2011-09-28 | 14321000M | 249d | 0d |  |  |  | FENKER H | 1 | 1 | HOWARD F |  |  |  |  |  |  |  |  | 10-069 |  |  |  | 11-026 | 11-046 | 12-012 |  |  |  |  |  |  |  |  |  |  | 09-022 |  |  |  |  |  |  |  |  |  |  |  |  |  | 07-024 | 08-016 | 09-012 |
| 143218P1LOE |  | P-1 Supervise Fab of Wire Chambs |  | 248d | 2009-10-01 | 2010-09-30 | 14321000M, 12232020 | 498d | 0d |  |  |  | FENKER H | 1 | 1 | HOWARD F |  |  |  |  |  |  |  |  | 10-069 |  |  |  | 11-026 | 11-046 |  |  |  |  |  |  |  |  |  |  |  | 09-022 |  |  |  |  |  |  |  |  |  |  |  |  |  | 07-024 |  | 09-012 |
| 14321007 |  | Procure Connectors and Components |  | 64d | 2010-07-01 | 2010-09-30 | 9-100M FS+184d | 743d | 494d |  | PROCUREMENT<$50K 60 | 50,000 | FENKER H | 1 | 1 | HOWARD F |  |  |  |  |  |  | 4315 | 10-057 | 10-069 |  |  |  | 11-026 | 11-046 |  |  |  |  |  |  |  |  |  |  |  |  |  |  |  |  |  |  |  |  |  |  |  |  |  |  |  |  |
| 143218P2LOE |  | P-2 Supervise Fab of Wire Chambs |  | 245d | 2010-10-01 | 2011-09-27 | 143218P1LOE | 498d | 249d |  | SCIENTIST [440 h] | 30,109.2 | FENKER H | 1 | 1 | HOWARD F |  |  |  |  |  |  |  |  | 10-069 |  |  |  | 11-026 | 11-046 |  |  |  |  |  |  |  |  |  |  |  | 09-022 |  |  |  |  |  |  |  |  |  |  |  |  |  | 07-024 |  | 09-012 |
| 14321900 |  | Proc Prep and Fab of Drift Gas Manifold Parts Original |  | 2d | 2012-01-30 | 2012-01-31 | 14324001a | 417d |  |  | MECH DES [8 h] | 385.36 | FENKER H | 1 | 1 | HOWARD F |  |  |  |  |  |  |  |  | 10-069 |  |  | 11-025 |  | 11-046 |  |  |  |  |  |  |  |  |  |  |  |  | 12-022 |  |  |  |  |  |  |  |  |  |  |  |  |  |  |  |
| 14321900a |  | Reverse Entry per CR12-022 |  | 2d | 2012-02-03 | 2012-02-06 | 9-120M FS+80d | 165d |  |  | MECH DES [-8 h] | -385.36 | FENKER H | 1 | 1 | HOWARD F |  |  |  |  |  |  |  |  |  |  |  |  |  |  |  |  |  |  |  |  |  |  |  |  |  |  | 12-022 |  |  |  |  |  |  |  |  |  |  |  |  |  |  |  |
| 14321905 |  | Refurbish LVPS |  | 120d | 2012-02-03 | 2012-07-24 | 9-120M FS+80d | 295d |  |  | ELEC TECH [240 h] | 10,591.2 | FENKER H | 1 | 1 | HOWARD F |  |  |  |  |  |  |  |  | 10-069 |  |  | 11-025 |  | 11-046 | 12-012 |  |  |  |  |  |  |  |  |  |  |  |  |  |  |  |  |  |  |  |  |  |  |  |  |  |  |  |
| 14321015M |  | Test Wire Chambers at University | milestone | 0d | 2012-09-27 | 2012-09-27 | 14321007, 14321005 FS+248d, 143218P2LOE | 249d |  |  |  |  | FENKER H | 1 | 1 | HOWARD F |  |  |  |  |  |  |  |  | 10-069 |  |  |  | 11-026 | 11-046 | 12-012 |  |  |  |  |  |  |  |  |  |  | 09-022 |  |  |  |  |  |  |  |  |  |  |  |  | 6 |  |  |  |
| 14321900b |  | Proc Prep and Fab of Drift Gas Manifold Parts Revised per CR12-022 |  | 104d | 2013-01-03 | 2013-05-31 | 9-130M FS+60d, 14324001a | 84d |  |  | PROCUREMENT<$50K 60; MECH DES [80 h] | 25,952.5 | FENKER H | 1 | 1 | HOWARD F |  |  |  |  |  |  |  |  |  |  |  |  |  |  |  |  |  |  |  |  |  |  |  |  |  |  | 12-022 |  |  |  |  |  |  |  | 12-054 |  |  |  |  |  |  |  |
| 14321910 |  | Re-Baseline Actuals Adjustment |  | 1d | 2013-08-30 | 2013-08-30 | 9-130M FS+227d | 20d |  |  | PROCUREMENT>$50K 69 NO ESCALATION | -11,332.83 | FENKER H | 1 | 1 | HOWARD F |  | 13-014 | ADJ |  |  |  |  |  |  |  |  |  |  |  |  |  |  |  |  |  |  |  |  |  |  |  |  |  |  |  |  |  |  |  |  |  |  |  |  |  |  |  |
| 24321007 |  | Procure Connectors and Components |  | 20d | 2013-09-03 | 2013-09-30 | 9-130M FS+228d | 504d | 228d | 8/5 M-F w/JLAB Holidays ReBaseline | PROCUREMENT<$50K 60 |  | FENKER H | 1 | 1 | HOWARD F | 13-006F |  |  | 24321007 |  | D | 4315 | 10-057 | 10-069 |  |  |  | 11-026 | 11-046 |  |  |  | PE | 13-015 | PR |  |  |  |  |  |  |  | OPEN OBLIGATION |  |  |  | Review |  |  |  |  |  |  |  |  |  |  |
| 24321015M |  | Test Wire Chambers at University | milestone | 0d | 2014-09-03 | 2014-09-03 | 9-140M FS+228d, 24321007 | 276d | 250d | 8/5 M-F w/JLAB Holidays ReBaseline |  |  | FENKER H | 1 | 1 | HOWARD F | 13-006F |  |  | 24321015M |  | Z |  |  | 10-069 |  |  |  | 11-026 | 11-046 | 12-012 |  |  |  | 13-015 | PR |  |  |  |  |  | 09-022 |  |  |  |  |  |  |  |  |  |  |  |  | 6 |  |  |  |

Notes:
- 24315036a5: Steps: Procure rotation system hardware; Proc licenses for intfc hdwr & sftwr
- 24315037b: Steps: Software programming 25% done; Software programming 50% done; Software programming 75% done; Software programming Completed; Software Checkout; Software Documentation; HMI Development 50% done; HMI Development Completed; Program remote rotation system; Develop rotation HMI; Proc. Prep for Software Licences; Install procured software
- 24315037ba: Steps: Software programming 25% done; Software programming 50% done; Software programming 75% done; Software programming Completed; Software Checkout; Software Documentation; HMI Development 50% done; HMI Development Completed; Program remote rotation system; Develop rotation HMI; Proc. Prep for Software Licences; Install procured software
- 24315007: Explanation: IPL from 6 GeV 54342005

| ID | WBS | Activity | Type | Duration | Start | Finish | Predecessors | Total float | Free float | Calendar | Resources | Cost | RESP - Responsibility | STRT%COMP for CM EVM | FNSH%COMP for CM EVM | Milestone Level | CAM RESPONSIBLE | CR 09-022 | CR 10-069 | CR 11-026 | CR 11-046 | CR 07-024 | CR 08-016 | CR 09-012 | CR 13-014 | ReBaseline Actuals Adjustment | CR 13-006 | CR 12-053 | BOE NOTES | Original Activity ID Rebaseline | Over Under Fixed | EVMS Reporting Codes | BOE Procurement | CR 13-015 | Post Rebaseline | Obligated Prior to Rebaseline | BOE Labor | Previously In Progress | CR 14-001 | CR 12-001 | CR 12-022 | Activities with Steps |
| --- | --- | --- | --- | --- | --- | --- | --- | --- | --- | --- | --- | --- | --- | --- | --- | --- | --- | --- | --- | --- | --- | --- | --- | --- | --- | --- | --- | --- | --- | --- | --- | --- | --- | --- | --- | --- | --- | --- | --- | --- | --- | --- |
|  | 2 | **1.4.3.2.2 HODOSCOPE (Trigger Hodoscopes)** |  |  | 2009-10-01 | 2013-08-30 |  |  |  |  |  |  |  |  |  |  |  |  |  |  |  |  |  |  |  |  |  |  |  |  |  |  |  |  |  |  |  |  |  |  |  |  |
| 14322000M |  | Award Contract for Scintillator Hodoscope Planes | milestone | 0d | 2009-10-01 | 2009-10-01 | 9-100M | 495d | 0d |  |  |  | FENKER H | 1 | 1 | 6 | HOWARD F | 09-022 | 10-069 | 11-026 | 11-046 |  |  |  |  |  |  |  |  |  |  |  |  |  |  |  |  |  |  |  |  |  |
| 14322005M |  | Award Contract for Quartz Hodoscope Planes | milestone | 0d | 2009-10-01 | 2009-10-01 | 9-100M | 495d | 0d |  |  |  | FENKER H | 1 | 1 | 6 | HOWARD F | 09-022 | 10-069 | 11-026 | 11-046 |  |  |  |  |  |  |  |  |  |  |  |  |  |  |  |  |  |  |  |  |  |
| 14322010 |  | Fab 3 Scintillator Planes (incl Supprt) (HODOSCP) |  | 496d | 2009-10-01 | 2011-09-30 | 14322000M, 122322005 | 495d |  |  |  |  | FENKER H | 1 | 1 |  | HOWARD F | 09-022 | 10-069 | 11-026 | 11-046 | 07-024 | 08-016 | 09-012 |  |  |  |  |  |  |  |  |  |  |  |  |  |  |  |  |  |  |
| 14322015 |  | Fab 1 Quartz Hodoscope Plane |  | 496d | 2009-10-01 | 2011-09-30 | 14322005M, 122322015b | 495d |  |  |  |  | FENKER H | 1 | 1 |  | HOWARD F | 09-022 | 10-069 | 11-026 | 11-046 | 07-024 | 08-016 | 09-012 |  |  |  |  |  |  |  |  |  |  |  |  |  |  |  |  |  |  |
| 14322013 |  | Detail Quartz Hodoscope Mounts |  | 110d | 2011-03-04 | 2011-08-08 | 14322005M, 9-110M FS+100d | 533d |  |  | MECH DES [400 h]; MECH ENG [80 h] | 24,108 | FENKER H | 1 | 1 |  | HOWARD F | 09-022 | 10-069 | 11-026 | 11-046 | 07-024 | 08-016 | 09-012 |  |  |  |  |  |  |  |  |  |  |  |  |  |  |  |  |  |  |
| 14322020 |  | Re-Baseline Actuals Adjustment |  | 1d | 2013-08-30 | 2013-08-30 | 9-130M FS+227d | 20d |  |  | PROCUREMENT>$50K 69 NO ESCALATION | 2,135.01 | FENKER H | 1 | 1 |  | HOWARD F |  |  |  |  |  |  |  | 13-014 | ADJ |  |  |  |  |  |  |  |  |  |  |  |  |  |  |  |  |
|  | 3 | **1.4.3.2.3 NOBLE GAS CERENKOV** |  |  | 2012-01-05 | 2014-07-31 |  |  |  |  |  |  |  |  |  |  |  |  |  |  |  |  |  |  |  |  |  |  |  |  |  |  |  |  |  |  |  |  |  |  |  |  |
| 14323000M |  | Award Contract for Noble Gas Cerenkov to University | milestone | 0d | 2012-01-05 | 2012-01-05 | 9-120M FS+60d | 45d | 0d |  |  |  | FENKER H | 1 | 1 | 6 | HOWARD F |  | 10-069 | 11-026 | 11-046 |  |  |  |  |  | 13-006F |  |  |  |  |  |  |  |  |  |  |  |  |  |  |  |
| 14323005 |  | Fab Noble Gas Cerenkov FY12 |  | 187d | 2012-01-05 | 2012-09-28 | 14323000M | 168d | 0d |  | PLABOR; CONTRB UNIV LBR [364.19 h]; MECH DES [280.15 h]; PD UNIV STAFF [672.36 h] | 60,747.49 | FENKER H | 1 | 1 |  | HOWARD F | 09-022 | 10-069 | 11-026 | 11-046 |  | 08-016 | 09-012 |  |  |  | 12-053 |  |  |  |  |  |  |  |  |  |  |  |  |  |  |
| 14323005b |  | Fab Noble Gas Cerenkov Procurement |  | 267d | 2012-01-05 | 2013-01-31 | 14323000M | 168d |  |  | PROCUREMENT<$50K 60 NO ESCALATION FY13 | 53,246.97 | FENKER H | 1 | 1 |  | HOWARD F | 09-022 | 10-069 | 11-026 | 11-046 |  | 08-016 | 09-012 |  |  |  | 12-053 |  |  |  |  |  |  |  |  |  |  |  |  |  |  |
| 14323010 |  | Design & Build Vacuum Box |  | 130d | 2012-01-05 | 2012-07-10 | 14323000M | 45d | 0d |  | MECH DES [200 h]; MECH ENG [80 h]; PROCUREMENT<$50K 60 | 41,864.04 | FENKER H | 1 | 1 |  | HOWARD F | 09-022 | 10-069 | 11-026 | 11-046 |  | 08-016 | 09-012 |  |  | 13-006F |  |  |  |  |  |  |  |  |  |  |  |  |  |  |  |
| 143238P1LOE |  | P-1 Supervise Constrctn of Noble Gas Cerenkov FY12 |  | 187d | 2012-01-05 | 2012-09-28 | 122323015, 14323000M | 1010d | 0d |  | SCIENTIST [112.06 h] | 7,912.56 | FENKER H | 1 | 1 |  | HOWARD F | 09-022 | 10-069 | 11-026 | 11-046 |  |  |  |  |  | 13-006F | 12-053 |  |  |  |  |  |  |  |  |  |  |  |  |  |  |
| 14323005a |  | Fab Noble Gas Cerenkov FY13 |  | 80d | 2012-10-01 | 2013-01-31 | 14323005 | 168d |  |  | PLABOR; CONTRB UNIV LBR [155.81 h]; MECH DES [119.85 h]; PD UNIV STAFF [287.64 h] | 26,816.88 | FENKER H | 1 | 1 |  | HOWARD F | 09-022 | 10-069 | 11-026 | 11-046 |  | 08-016 | 09-012 |  |  |  | 12-053 |  |  |  |  |  |  |  |  |  |  |  |  |  |  |
| 143238P1LOEa |  | P-1 Supervise Constrctn of Noble Gas Cerenkov FY13 |  | 80d | 2012-10-01 | 2013-01-31 | 143238P1LOE | 1010d | 0d |  | SCIENTIST [47.94 h] | 3,492.91 | FENKER H | 1 | 1 |  | HOWARD F | 09-022 | 10-069 | 11-026 | 11-046 |  |  |  |  |  | 13-006F | 12-053 |  |  |  |  |  |  |  |  |  |  |  |  |  |  |
| 14323015 |  | Detailing Cerenkov-to-Magnet Interface |  | 130d | 2013-01-23 | 2013-07-26 | 14323010 FS+130d | 45d |  |  | MECH DES [200 h]; MECH ENG [80 h] | 15,730.8 | FENKER H | 1 | 1 |  | HOWARD F |  |  |  |  |  |  |  |  |  | 13-006 |  |  |  |  |  |  |  |  |  |  |  |  |  |  |  |
| 143238P1LOEb |  | P-2 Supervise Constrctn of Noble Gas Cerenkov |  | 148d | 2013-02-01 | 2013-08-30 | 143238P1LOEa | 1010d | 1073d |  | SCIENTIST [98.67 h] | 7,189.1 | FENKER H | 1 | 1 |  | HOWARD F |  |  |  |  |  |  |  | 13-014 |  | 13-006 |  |  |  |  |  |  |  |  |  |  |  |  |  |  |  |
| 14323020 |  | Re-Baseline Actuals Adjustment |  | 1d | 2013-08-30 | 2013-08-30 | 9-130M FS+227d | 20d |  |  | PROCUREMENT>$50K 69 NO ESCALATION | -44,101.9 | FENKER H | 1 | 1 |  | HOWARD F |  |  |  |  |  |  |  | 13-014 | ADJ |  |  |  |  |  |  |  |  |  |  |  |  |  |  |  |  |
| 24323005b |  | Fab Noble Gas Cerenkov Procurement |  | 225d | 2013-09-03 | 2014-07-31 | 9-130M FS+228d | 264d | 220d | 8/5 M-F w/JLAB Holidays ReBaseline | PROCUREMENT>$50K 69 NO ESCALATION; PROCUREMENT<$50K 60 NO ESCALATION | 111,881.18 | FENKER H | 1 | 1 |  | HOWARD F | 09-022 | 10-069 | 11-026 | 11-046 |  | 08-016 | 09-012 |  |  | 13-006F | 12-053 | OPEN OBLIGATION | 24323005b | y | D | OB | 13-015 | PR | OB |  |  |  |  |  |  |
| 24323012 |  | Build Vacuum Box |  | 62d | 2013-09-03 | 2013-11-27 | 9-130M FS+228d | 462d | 436d | 8/5 M-F w/JLAB Holidays ReBaseline | PROCUREMENT<$50K 60 NO ESCALATION FY14 | 13,108.81 | FENKER H | 1 | 1 |  | HOWARD F | 09-022 | 10-069 | 11-026 | 11-046 |  | 08-016 | 09-012 |  |  | 13-006F |  | OPEN OBLIGATION | 24323012 | y | D | EJ | 13-015 | PR | OB | EJ | Review |  |  |  |  |
| 243238P1LOEb |  | P-2 Supervise Constrctn of Noble Gas Cerenkov |  | 20d | 2013-09-03 | 2013-09-30 | 9-130M FS+228d | 551d |  | 8/5 M-F w/JLAB Holidays ReBaseline | SCIENTIST [13.33 h] | 971.22 | FENKER H | 1 | 1 |  | HOWARD F |  |  |  |  |  |  |  |  |  | 13-006 |  |  | 243238P1LOEb |  | E |  | 13-015 | PR |  | PE |  |  |  |  |  |
| 24323025 |  | Install NGC Gas Mixer in Gas Shed |  | 20d | 2013-11-01 | 2013-12-02 | 9-140M FS+23d | 461d | 435d | 8/5 M-F w/JLAB Holidays ReBaseline | MECH TECH [80 h] | 3,785.6 | FENKER H | 1 | 1 |  | HOWARD F |  |  |  |  |  |  |  |  |  | 13-006 |  |  | 24323025 |  | H |  | 13-015 | PR |  | EJ |  | 14-001 |  |  |  |
|  | 4 | **1.4.3.2.4 HEAVY GAS CERENKOV** |  |  | 2011-06-06 | 2014-07-31 |  |  |  |  |  |  |  |  |  |  |  |  |  |  |  |  |  |  |  |  |  |  |  |  |  |  |  |  |  |  |  |  |  |  |  |  |
| 14324000 |  | Engineering & Design Oversite FY11 |  | 83d | 2011-06-06 | 2011-09-30 | 9-110M FS+165d | 1160d | 0d |  | MECH DES [117.73 h]; MECH ENG [117.73 h] | 13,495.39 | FENKER H | 1 | 1 |  | HOWARD F | 09-022 | 10-069 | 11-026 | 11-046 |  | 08-016 | 09-012 |  |  |  |  |  |  |  |  |  |  |  |  |  |  |  | 12-001 |  |  |
| 14324001 |  | Engineering & Design - Gas System FY11 |  | 83d | 2011-06-06 | 2011-09-30 | 9-110M FS+165d | 291d | 0d |  | MECH DES [208.8 h]; MECH ENG [104.4 h]; SCIENTIST [104.4 h] | 23,984.85 | FENKER H | 1 | 1 |  | HOWARD F | 09-022 | 10-069 | 11-026 | 11-046 |  | 08-016 | 09-012 |  |  | 13-006F |  |  |  |  |  |  |  |  |  |  |  |  | 12-001 |  |  |
| 14324000a |  | Engineering & Design Oversite FY12 |  | 58d | 2011-10-03 | 2011-12-30 | 14324000 | 1160d | 2d |  | MECH DES [82.27 h]; MECH ENG [82.27 h] | 9,731.72 | FENKER H | 1 | 1 |  | HOWARD F | 09-022 | 10-069 | 11-026 | 11-046 |  | 08-016 | 09-012 |  |  |  |  |  |  |  |  |  |  |  |  |  |  |  | 12-001 |  |  |
| 14324001a |  | Engineering & Design - Gas System FY12 |  | 76d | 2011-10-03 | 2012-01-27 | 14324001 | 291d | 0d |  | MECH DES [191.2 h]; MECH ENG [95.6 h]; SCIENTIST [95.6 h] | 22,663.89 | FENKER H | 1 | 1 |  | HOWARD F | 09-022 | 10-069 | 11-026 | 11-046 |  | 08-016 | 09-012 |  |  | 13-006F |  |  |  |  |  |  |  |  |  |  |  |  | 12-001 |  |  |
| 14324010 |  | Ship and Aluminize Mirrors |  | 267d | 2012-01-05 | 2013-01-31 | 9-120M FS+60d | 168d |  |  | PROCUREMENT<$50K 60 NO ESCALATION FY13 | 19,166.72 | FENKER H | 1 | 1 |  | HOWARD F | 09-022 | 10-069 | 11-026 | 11-046 |  | 08-016 | 09-012 |  |  |  |  |  |  |  |  |  |  |  |  |  |  |  |  |  |  |
| 143248P1LOE |  | P-1 Supervise Constrctn of Heavy Gas Cerenkov FY12 |  | 187d | 2012-01-05 | 2012-09-28 | 9-120M FS+60d, 14324000a, 122324015 | 1158d | 0d |  | SCIENTIST [112.06 h] | 7,912.56 | FENKER H | 1 | 1 |  | HOWARD F | 09-022 | 10-069 | 11-026 | 11-046 |  |  |  |  |  |  | 12-053 |  |  |  |  |  |  |  |  |  |  |  |  |  |  |
| 14324003 |  | Fab Gas System Original |  | 2d | 2012-01-30 | 2012-01-31 | 14324001a | 417d |  |  | MECH TECH [20 h]; MECH DES [6.67 h] | 1,210.09 | FENKER H | 1 | 1 |  | HOWARD F | 09-022 | 10-069 | 11-026 | 11-046 |  | 08-016 | 09-012 |  |  |  |  |  |  |  |  |  |  |  |  |  |  |  |  | 12-022 |  |
| 14324003a |  | Reverse Entry per CR12-022 |  | 2d | 2012-02-03 | 2012-02-06 | 9-120M FS+80d | 165d |  |  | MECH TECH [-20 h]; MECH DES [-6.67 h] | -1,210.09 | FENKER H | 1 | 1 |  | HOWARD F | 09-022 | 10-069 | 11-026 | 11-046 |  | 08-016 | 09-012 |  |  |  |  |  |  |  |  |  |  |  |  |  |  |  |  | 12-022 |  |
| 143248P1LOE5 |  | P-1 Supervise Constrctn of Heavy Gas Cerenkov FY13 |  | 80d | 2012-10-01 | 2013-01-31 | 143248P1LOE | 1158d | 1221d |  | SCIENTIST [47.94 h] | 3,492.91 | FENKER H | 1 | 1 |  | HOWARD F | 09-022 | 10-069 | 11-026 | 11-046 |  |  |  |  |  |  | 12-053 |  |  |  |  |  |  |  |  |  |  |  |  |  |  |
| 14324003b |  | Fab Gas System Revised per CR12-022-- Procurement |  | 60d | 2013-03-04 | 2013-05-24 | 14324001a, 9-130M FS+100d | 20d | 0d |  | MECH DES [200 h]; PROCUREMENT<$50K 60; MECH TECH | 92,350.9 | FENKER H | 1 | 1 |  | HOWARD F | 09-022 | 10-069 | 11-026 | 11-046 |  | 08-016 | 09-012 |  |  | 13-006 |  |  |  |  |  |  |  |  |  |  |  |  |  | 12-022 |  |
| 14324005 |  | ASSEMBLE Gas System |  | 68d | 2013-05-28 | 2013-08-30 | 14324003b | 20d |  |  | MECH TECH [185.03 h] | 8,485.48 | FENKER H | 1 | 1 |  | HOWARD F | 09-022 | 10-069 | 11-026 | 11-046 |  | 08-016 | 09-012 | 13-014 |  | 13-006 |  |  |  |  |  |  |  |  |  |  |  |  |  | 12-022 |  |
| 14324015 |  | Re-Baseline Actuals Adjustment |  | 1d | 2013-08-30 | 2013-08-30 | 9-130M FS+227d | 20d |  |  | PROCUREMENT>$50K 69 NO ESCALATION | -81,154.79 | FENKER H | 1 | 1 |  | HOWARD F |  |  |  |  |  |  |  | 13-014 | ADJ |  |  |  |  |  |  |  |  |  |  |  |  |  |  |  |  |
| 24324005 |  | Assemble HGC Gas System & Leak-check tank |  | 20d | 2014-07-03 | 2014-07-31 | 9-140M FS+185d | 281d | 0d | 8/5 M-F w/JLAB Holidays ReBaseline | MECH TECH [320 h] | 15,142.4 | FENKER H | 1 | 1 |  | HOWARD F | 09-022 | 10-069 | 11-026 | 11-046 |  | 08-016 | 09-012 |  |  | 13-006 |  |  | 24324005 |  | S |  | 13-015 | PR |  | PE |  | 14-001 |  | 12-022 | ST |

Notes:
- 14324003: Explanation: "S" History change of 2 Days per CR 12-022 PMK / 2/10/12
- 14324003a: Explanation: "S" History change of 2 Days per CR 12-022 PMK / 2/10/12
- 14324003b: Explanation: "S" History change of 2 Days per CR 12-022 PMK / 2/10/12
- 14324005: Explanation: "S" History change of 2 Days per CR 12-022 PMK / 2/10/12
- 24324005: Explanation: "S" History change of 2 Days per CR 12-022 PMK / 2/10/12 / Steps: Assemble HGC Gas System Piping; Test & Leak-Check entire HGC Gas System in shop

| ID | WBS | Activity | Duration | Start | Finish | Predecessors | Total float | Free float | Calendar | Resources | Cost | RESP - Responsibility | STRT%COMP for CM EVM | FNSH%COMP for CM EVM | CR 07-024 | Profile change | CAM RESPONSIBLE | CR 09-012 | CR 09-022 | CR 10-069 | CR 11-025 | CR 11-026 | CR 11-046 | CR 12-012 | CR 12-014 | CR 12-047 | CR 13-014 | ReBaseline Actuals Adjustment | BOE NOTES | Original Activity ID Rebaseline | Over Under Fixed | EVMS Reporting Codes | BOE Procurement | CR 13-015 | Post Rebaseline | Obligated Prior to Rebaseline | CR 13-006 | BOE Labor | CR 14-001 | 12 GEV MAJOR PROCUREMENT CATAGORY | CR 10-057 | CR 08-016 | CR 12-053 | CR 12-055 |
| --- | --- | --- | --- | --- | --- | --- | --- | --- | --- | --- | --- | --- | --- | --- | --- | --- | --- | --- | --- | --- | --- | --- | --- | --- | --- | --- | --- | --- | --- | --- | --- | --- | --- | --- | --- | --- | --- | --- | --- | --- | --- | --- | --- | --- |
|  | 5 | **1.4.3.2.5 SHOWER COUNTER** |  | 2011-05-31 | 2013-12-20 |  |  |  |  |  |  |  |  |  |  |  |  |  |  |  |  |  |  |  |  |  |  |  |  |  |  |  |  |  |  |  |  |  |  |  |  |  |  |  |
| 14325027c |  | Procure SD for Calorimeter Ref. Hall D 1543055 | 66d | 2011-05-31 | 2011-08-31 | 9-110M FS+161d | 516d |  |  | PROCUREMENT<$50K 60 | 2,500 | FENKER H | 1 | 1 | 07-024 | C | HOWARD F | 09-012 | 09-022 | 10-069 | 11-025 | 11-026 | 11-046 |  |  |  |  |  |  |  |  |  |  |  |  |  |  |  |  |  |  |  |  |  |
| 14325027a |  | Procure CTP for Calorimeter Ref. Hall D 1543025 | 37d | 2011-07-12 | 2011-08-31 | 9-110M FS+190d | 516d |  |  | PROCUREMENT<$50K 60 | 5,000 | FENKER H | 1 | 1 | 07-024 | C | HOWARD F | 09-012 | 09-022 | 10-069 | 11-025 | 11-026 | 11-046 |  |  |  |  |  |  |  |  |  |  |  |  |  |  |  |  |  |  |  |  |  |
| 14325027b |  | Procure TI for Calorimeter Ref. Hall D 1543040 | 28d | 2011-09-08 | 2011-10-17 | 9-110M FS+231d | 484d |  |  | PROCUREMENT<$50K 60 NO ESCALATION FY12 | 1,850 | FENKER H | 1 | 1 | 07-024 | C | HOWARD F | 09-012 | 09-022 | 10-069 | 11-025 | 11-026 | 11-046 | 12-012 |  |  |  |  |  |  |  |  |  |  |  |  |  |  |  |  |  |  |  |  |
| 14325005 |  | Buy Lead Glass Blocks (SHOWER COUNTER) | 130d | 2011-10-03 | 2012-04-13 | 9-120M, 122325020 | 305d | 0d |  |  |  | FENKER H | 1 | 1 | 07-024 |  | HOWARD F | 09-012 |  | 10-069 |  | 11-026 | 11-046 |  |  |  |  |  |  |  |  |  |  |  |  |  |  |  |  |  |  |  |  |  |
| 14325027 |  | Procure F250 ADCs (SHOWER COUNTER) | 231d | 2012-01-04 | 2012-11-30 | 9-120M FS+59d | 128d | 0d |  | PROCUREMENT<$50K 60 NO ESCALATION; PROCUREMENT>$50K 69 NO ESCALATION | 74,378.41 | FENKER H | 1 | 1 | 07-024 | C | HOWARD F | 09-012 | 09-022 | 10-069 | 11-025 | 11-026 |  |  | 12-014 | 12-047F |  |  |  |  |  |  |  |  |  |  |  |  |  |  |  |  |  |  |
| 14325010 |  | Buy PMTs & Bases (SHOWER COUNTER) | 60d | 2012-04-16 | 2012-07-10 | 14325005 | 305d |  |  |  |  | FENKER H | 1 | 1 | 07-024 |  | HOWARD F | 09-012 |  | 10-069 |  | 11-026 | 11-046 |  |  |  |  |  |  |  |  |  |  |  |  |  |  |  |  |  |  |  |  |  |
| 14325028 |  | UMASS - Testing of F250 ADCs by University (SHOWER COUNTER) REFERENCE 1541057 | 98d | 2012-10-31 | 2013-03-29 | 14325027 FS-21d | 128d |  |  | PROCUREMENT<$50K 60 NO ESCALATION | 5,000 | FENKER H | 1 | 1 | 07-024 | C | HOWARD F | 09-012 | 09-022 | 10-069 | 11-025 | 11-026 |  | 12-012 | 12-014 | 12-047 |  |  |  |  |  |  |  |  |  |  |  |  |  |  |  |  |  |  |
| 14325015 |  | Fab Supprt Sys (SHOWER COUNTER) | 10d | 2013-04-01 | 2013-04-12 | 14363030, 14363030a, 14325005 | 118d |  |  |  |  | FENKER H | 1 | 1 | 07-024 |  | HOWARD F | 09-012 | 09-022 | 10-069 | 11-025 | 11-026 | 11-046 |  |  |  |  |  |  |  |  |  |  |  |  |  |  |  |  |  |  |  |  |  |
| 14325030 |  | Re-Baseline Actuals Adjustment | 1d | 2013-08-30 | 2013-08-30 | 9-130M FS+227d | 20d |  |  | PROCUREMENT>$50K 69 NO ESCALATION | -8,734.67 | FENKER H | 1 | 1 |  |  | HOWARD F |  |  |  |  |  |  |  |  |  | 13-014 | ADJ |  |  |  |  |  |  |  |  |  |  |  |  |  |  |  |  |
| 24325027a |  | Procure CTP for Calorimeter Ref. Hall D 1543025 | 20d | 2013-09-03 | 2013-09-30 | 9-130M FS+228d | 401d | 140d | 8/5 M-F w/JLAB Holidays ReBaseline | PROCUREMENT>$50K 69; PROCUREMENT<$50K 60 | 4,502.29 | FENKER H | 1 | 1 | 07-024 | C | HOWARD F | 09-012 | 09-022 | 10-069 | 11-025 | 11-026 | 11-046 |  |  |  |  |  | OPEN OBLIGATION | 24325027a | y | D | OB | 13-015 | PR | OB |  |  |  |  |  |  |  |  |
| 24325030 |  | Fiducialize SHMS Shower Counter (Frame) | 57d | 2013-10-01 | 2013-12-20 | 9-140M | 342d | 43d | 8/5 M-F w/JLAB Holidays ReBaseline | MECH TECH [16 h] | 757.12 | FENKER H | 1 | 1 |  |  | HOWARD F |  |  |  |  |  |  |  |  |  |  |  |  | 24325030 |  | H |  | 13-015 | PR |  | 13-006 | PE | 14-001 |  |  |  |  |  |
|  | 6 | **1.4.3.2.6 AEROGEL CERENKOV** |  |  |  |  |  |  |  |  |  |  |  |  |  |  |  |  |  |  |  |  |  |  |  |  |  |  |  |  |  |  |  |  |  |  |  |  |  |  |  |  |  |  |
|  | 7 | **1.4.3.2.7 TRD** |  |  |  |  |  |  |  |  |  |  |  |  |  |  |  |  |  |  |  |  |  |  |  |  |  |  |  |  |  |  |  |  |  |  |  |  |  |  |  |  |  |  |
|  | 8 | **1.4.3.2.8 DETECTOR FRAME** |  | 2010-06-01 | 2014-03-31 |  |  |  |  |  |  |  |  |  |  |  |  |  |  |  |  |  |  |  |  |  |  |  |  |  |  |  |  |  |  |  |  |  |  |  |  |  |  |  |
| 14328015 |  | Procure Support Frame | 86d | 2010-06-01 | 2010-09-30 | 9-100M FS+162d | 743d |  |  | PROCUREMENT<$50K 60 | 28,000 | FENKER H | 1 | 1 |  |  | HOWARD F |  |  | 10-069 |  | 11-026 | 11-046 |  |  |  |  |  |  |  |  |  |  |  |  |  |  |  |  | 4315 | 10-057 |  |  |  |
| 14328005 |  | Fab General Struct for Detector Frame FY12 | 225d | 2011-11-02 | 2012-09-28 | 9-120M FS+22d, 122325020 | 228d | 0d |  | MECH DES [257.14 h]; TRAVEL; SUPPLIES & MATERIALS; MECH ENG [110.2 h]; MECH TECH [367.35 h]; PLABOR; MSHOP | 70,704.32 | FENKER H | 1 | 1 |  |  | HOWARD F | 09-012 |  | 10-069 |  | 11-026 | 11-046 |  |  |  |  |  |  |  |  |  |  |  |  |  |  |  |  |  |  | 08-016 | 12-053 |  |
| 14328005b |  | Fab General Struct for Detector Frame Procurement Part A | 245d | 2011-11-02 | 2012-10-26 | 9-120M FS+22d, 122325020 | 228d |  |  | PROCUREMENT>$50K 69 NO ESCALATION FY13; PROCUREMENT<$50K 60 NO ESCALATION FY13 | 177,820.34 | FENKER H | 1 | 1 |  |  | HOWARD F | 09-012 |  | 10-069 |  | 11-026 | 11-046 |  |  |  |  |  |  |  |  |  |  |  |  |  |  |  |  |  |  | 08-016 | 12-053 | 12-055 |
| 14328005ba |  | Fab General Struct for Detector Frame Procurement Part B | 245d | 2011-11-02 | 2012-10-26 | 9-120M FS+22d, 122325020 | 228d |  |  | PROCUREMENT>$50K 69 NO ESCALATION FY13 | 8,000 | FENKER H | 1 | 1 |  |  | HOWARD F | 09-012 |  | 10-069 |  | 11-026 | 11-046 |  |  |  |  |  |  |  |  |  |  |  |  |  |  |  |  |  |  | 08-016 | 12-053 | 12-055 |
| 14328010 |  | Fab Supprt for individual Detctr's FY12 | 225d | 2011-11-02 | 2012-09-28 | 9-120M FS+22d, 122325020 | 171d | 0d |  | MECH DES [238.41 h]; MECH TECH [298.01 h]; MSHOP; MECH ENG [119.21 h] | 37,584.71 | FENKER H | 1 | 1 |  |  | HOWARD F | 09-012 | 09-022 | 10-069 |  | 11-026 | 11-046 |  |  |  |  |  |  |  |  |  |  |  |  |  |  |  |  |  |  | 08-016 | 12-053 |  |
| 14328010b |  | Fab Supprt for individual Detctr's Procurement Part A | 302d | 2011-11-02 | 2013-01-28 | 9-120M FS+22d, 122325020 | 171d |  |  | PROCUREMENT<$50K 60 NO ESCALATION FY13 | 17,400 | FENKER H | 1 | 1 |  |  | HOWARD F | 09-012 | 09-022 | 10-069 |  | 11-026 | 11-046 |  |  |  |  |  |  |  |  |  |  |  |  |  |  |  |  |  |  | 08-016 | 12-053 | 12-055 |
| 14328010ba |  | Fab Supprt for individual Detctr's Procurement Part B | 302d | 2011-11-02 | 2013-01-28 | 9-120M FS+22d, 122325020 | 171d |  |  | PROCUREMENT<$50K 60 NO ESCALATION FY13 | 25,948.72 | FENKER H | 1 | 1 |  |  | HOWARD F | 09-012 | 09-022 | 10-069 |  | 11-026 | 11-046 |  |  |  |  |  |  |  |  |  |  |  |  |  |  |  |  |  |  | 08-016 | 12-053 | 12-055 |
| 14328005a |  | Fab General Struct for Detector Frame FY13 | 20d | 2012-10-01 | 2012-10-26 | 14328005 | 228d |  |  | MECH ENG [9.8 h]; MECH TECH [32.65 h]; PLABOR; MSHOP; MECH DES [22.86 h]; TRAVEL; SUPPLIES & MATERIALS | 6,485.81 | FENKER H | 1 | 1 |  |  | HOWARD F | 09-012 |  | 10-069 |  | 11-026 | 11-046 |  |  |  |  |  |  |  |  |  |  |  |  |  |  |  |  |  |  | 08-016 | 12-053 |  |
| 14328010a |  | Fab Supprt for individual Detctr's FY13 | 77d | 2012-10-01 | 2013-01-28 | 14328010 | 171d |  |  | MECH ENG [40.79 h]; MECH DES [81.59 h]; MECH TECH [101.99 h]; MSHOP | 13,273.05 | FENKER H | 1 | 1 |  |  | HOWARD F | 09-012 | 09-022 | 10-069 |  | 11-026 | 11-046 |  |  |  |  |  |  |  |  |  |  |  |  |  |  |  |  |  |  | 08-016 | 12-053 |  |
| 14328020 |  | Re-Baseline Actuals Adjustment | 1d | 2013-08-30 | 2013-08-30 | 9-130M FS+227d | 20d |  |  | PROCUREMENT>$50K 69 NO ESCALATION | -213,887.2 | FENKER H | 1 | 1 |  |  | HOWARD F |  |  |  |  |  |  |  |  |  | 13-014 | ADJ |  |  |  |  |  |  |  |  |  |  |  |  |  |  |  |  |
| 24328005 |  | Calorimeter Support Frame TBP | 43d | 2013-09-03 | 2013-10-31 | 9-130M FS+228d | 370d | 20d | 8/5 M-F w/JLAB Holidays ReBaseline | PROCUREMENT<$50K 60 NO ESCALATION FY14 | 15,150 | FENKER H | 1 | 1 |  |  | HOWARD F | 09-012 |  | 10-069 |  | 11-026 | 11-046 |  |  |  |  |  |  | 24328005 | y | D | OB | 13-015 | PR | OB | 13-006F |  |  |  |  | 08-016 | 12-053 |  |
| 24328010ba |  | Fab Supprt for individual Detctr's Procurement Part B | 119d | 2013-10-01 | 2014-03-31 | 24328005 FS-43d, 9-140M | 350d | 306d | 8/5 M-F w/JLAB Holidays ReBaseline | PROCUREMENT<$50K 60 | 31,141.06 | FENKER H | 1 | 1 |  |  | HOWARD F | 09-012 | 09-022 | 10-069 |  | 11-026 | 11-046 |  |  |  |  |  |  | 24328010ba |  | D | EJ | 13-015 | PR |  | 13-006F |  | 14-001 |  |  | 08-016 | 12-053 | 12-055 |

Notes:
- 14325027c: Corrective Actions: TEMPORARY INPUT FROM ANTJE, BUT WILL HAVE TO BE COMPENSATED BY REDUCTIONS / FROM ELKE
- 14325027a: Corrective Actions: TEMPORARY INPUT FROM ANTJE, BUT WILL HAVE TO BE COMPENSATED BY REDUCTIONS / FROM ELKE
- 14325027b: Corrective Actions: TEMPORARY INPUT FROM ANTJE, BUT WILL HAVE TO BE COMPENSATED BY REDUCTIONS / FROM ELKE
- 14325027: Corrective Actions: TEMPORARY INPUT FROM ANTJE, BUT WILL HAVE TO BE COMPENSATED BY REDUCTIONS / FROM ELKE
- 14325028: Corrective Actions: TEMPORARY INPUT FROM ANTJE, BUT WILL HAVE TO BE COMPENSATED BY REDUCTIONS / FROM ELKE
- 24325027a: Corrective Actions: TEMPORARY INPUT FROM ANTJE, BUT WILL HAVE TO BE COMPENSATED BY REDUCTIONS / FROM ELKE

| ID | WBS | Activity | Duration | Start | Finish | Predecessors | Total float | Free float | Calendar | Resources | Cost | RESP - Responsibility | STRT%COMP for CM EVM | FNSH%COMP for CM EVM | CAM RESPONSIBLE | CR 13-014 | ReBaseline Actuals Adjustment | Original Activity ID Rebaseline | EVMS Reporting Codes | CR 10-069 | CR 11-025 | CR 11-026 | CR 11-046 | CR 12-022 | CR 13-006 | BOE Procurement | CR 13-015 | Post Rebaseline | CR 14-001 | CR 07-024 | CR 08-016 | CR 09-012 | CR 12-012 | CR 12-014 | Duplications | CR 12-053 | CR 12-054 | Activities with Steps | BOE Labor | Over Under Fixed | Obligated Prior to Rebaseline |
| --- | --- | --- | --- | --- | --- | --- | --- | --- | --- | --- | --- | --- | --- | --- | --- | --- | --- | --- | --- | --- | --- | --- | --- | --- | --- | --- | --- | --- | --- | --- | --- | --- | --- | --- | --- | --- | --- | --- | --- | --- | --- |
|  | 3 | **1.4.3.3 COMPUTING** |  | 2013-08-30 | 2014-12-02 |  |  |  |  |  |  |  |  |  |  |  |  |  |  |  |  |  |  |  |  |  |  |  |  |  |  |  |  |  |  |  |  |  |  |  |  |
|  | 1 | **1.4.3.3.1 DAQ** |  | 2013-08-30 | 2014-12-02 |  |  |  |  |  |  |  |  |  |  |  |  |  |  |  |  |  |  |  |  |  |  |  |  |  |  |  |  |  |  |  |  |  |  |  |  |
| 1433015 |  | Re-Baseline Actuals Adjustment | 1d | 2013-08-30 | 2013-08-30 | 9-130M FS+227d | 20d |  |  | PROCUREMENT>$50K 69 NO ESCALATION |  | FENKER H | 1 | 1 | HOWARD F | 13-014 | ADJ |  |  |  |  |  |  |  |  |  |  |  |  |  |  |  |  |  |  |  |  |  |  |  |  |
| 2433000 |  | Buy 5 Fast PC's for Data Acq & Processing (COMP) | 40d | 2014-10-06 | 2014-12-02 | 9-140M FS+250d | 186d | 0d | 8/5 M-F w/JLAB Holidays ReBaseline | PROCUREMENT<$50K 60 | 19,228.74 | FENKER H | 1 | 1 | HOWARD F |  |  | 2433000 | D | 10-069 | 11-025 | 11-026 | 11-046 | 12-022 | 13-006 | PE | 13-015 | PR | 14-001 |  |  |  |  |  |  |  |  |  |  |  |  |
| 2433005 |  | Buy File Servers for Data Acq System (COMP) | 40d | 2014-10-06 | 2014-12-02 | 9-140M FS+250d | 186d | 0d | 8/5 M-F w/JLAB Holidays ReBaseline | PROCUREMENT<$50K 60 | 12,458.43 | FENKER H | 1 | 1 | HOWARD F |  |  | 2433005 | D | 10-069 | 11-025 | 11-026 | 11-046 | 12-022 | 13-006 | PE | 13-015 | PR | 14-001 |  |  |  |  |  |  |  |  |  |  |  |  |
| 2433010 |  | Buy 8 Workstations/Monitors (COMP) | 40d | 2014-10-06 | 2014-12-02 | 9-140M FS+250d | 186d | 0d | 8/5 M-F w/JLAB Holidays ReBaseline | PROCUREMENT<$50K 60 | 12,458.43 | FENKER H | 1 | 1 | HOWARD F |  |  | 2433010 | D | 10-069 | 11-025 | 11-026 | 11-046 | 12-022 | 13-006 | PE | 13-015 | PR | 14-001 |  |  |  |  |  |  |  |  |  |  |  |  |
|  | 2 | **1.4.3.3.2 SLOW CONTROLS** |  |  |  |  |  |  |  |  |  |  |  |  |  |  |  |  |  |  |  |  |  |  |  |  |  |  |  |  |  |  |  |  |  |  |  |  |  |  |  |
|  | 4 | **1.4.3.4 ELECTRONICS** |  | 2010-11-12 | 2014-02-10 |  |  |  |  |  |  |  |  |  |  |  |  |  |  |  |  |  |  |  |  |  |  |  |  |  |  |  |  |  |  |  |  |  |  |  |  |
|  | 1 | **1.4.3.4.1 FAST ELECTRONICS** |  | 2011-05-13 | 2014-02-10 |  |  |  |  |  |  |  |  |  |  |  |  |  |  |  |  |  |  |  |  |  |  |  |  |  |  |  |  |  |  |  |  |  |  |  |  |
| 14341007 |  | SOS Signal Cable Prepare for Installation (FAST Electrnc's) | 60d | 2011-05-13 | 2011-08-08 | 4A-01M | 68d |  |  | ELEC TECH [400 h]; SUPPLIES & MATERIALS | 27,427 | FENKER H | 1 | 1 | HOWARD F |  |  |  |  | 10-069 |  |  | 11-046 |  |  |  |  |  |  | 07-024 | 08-016 | 09-012 |  |  |  |  |  |  |  |  |  |
| 14341015 |  | Proc ADCs for Hodoscopes (FAST Electrnc's) | 231d | 2012-01-04 | 2012-11-30 | 9-120M FS+59d | 205d |  |  | PROCUREMENT>$50K 69 NO ESCALATION; PROCUREMENT<$50K 60 NO ESCALATION | 53,717.74 | FENKER H | 1 | 1 | HOWARD F |  |  |  |  | 10-069 |  | 11-026 | 11-046 |  |  |  |  |  |  | 07-024 | 08-016 | 09-012 | 12-012 | 12-014 |  |  |  |  |  |  |  |
| 14341005 |  | Proc TDCs for Wire Chambers (FAST Electrnc's) | 245d | 2012-01-05 | 2012-12-21 | 9-120M FS+60d | 190d |  |  |  |  | FENKER H | 1 | 1 | HOWARD F |  |  |  |  | 10-069 |  | 11-026 | 11-046 |  |  |  |  |  |  | 07-024 | 08-016 | 09-012 |  |  |  |  |  |  |  |  |  |
| 14341010 |  | Proc Discriminators for Wire Chambers (FAST Electrnc's) | 130d | 2012-01-05 | 2012-07-10 | 9-120M FS+60d | 305d |  |  |  |  | FENKER H | 1 | 1 | HOWARD F |  |  |  |  | 10-069 |  | 11-026 | 11-046 |  |  |  |  |  |  | 07-024 |  | 09-012 |  |  |  |  |  |  |  |  |  |
| 14341020 |  | Proc ADCs for Calorimeter (FAST Electrnc's) FY12 | 187d | 2012-01-05 | 2012-09-28 | 9-120M FS+60d | 190d | 0d |  | SUPPLIES & MATERIALS | 1,625.48 | FENKER H | 1 | 1 | HOWARD F |  |  |  |  | 10-069 |  | 11-026 | 11-046 |  |  |  |  |  |  | 07-024 | 08-016 | 09-012 |  |  | DUP | 12-053 |  |  |  |  |  |
| 14341025 |  | Proc TDCs for Hodoscopes (FAST Electrnc's) | 245d | 2012-01-05 | 2012-12-21 | 9-120M FS+60d | 190d |  |  |  |  | FENKER H | 1 | 1 | HOWARD F |  |  |  |  | 10-069 |  | 11-026 | 11-046 |  |  |  |  |  |  | 07-024 | 08-016 | 09-012 |  |  |  |  |  |  |  |  |  |
| 14341030 |  | Proc Discriminators for Hodoscopes (FAST Electrnc's) | 245d | 2012-01-05 | 2012-12-21 | 9-120M FS+60d | 190d |  |  |  |  | FENKER H | 1 | 1 | HOWARD F |  |  |  |  | 10-069 |  | 11-026 | 11-046 |  |  |  |  |  |  | 07-024 | 08-016 | 09-012 |  |  |  |  |  |  |  |  |  |
| 14341035 |  | Proc HV for All Detctr's (FAST Electrnc's) | 245d | 2012-01-05 | 2012-12-21 | 9-120M FS+60d | 190d |  |  |  |  | FENKER H | 1 | 1 | HOWARD F |  |  |  |  | 10-069 |  | 11-026 | 11-046 |  |  |  |  |  |  | 07-024 | 08-016 | 09-012 |  |  |  |  |  |  |  |  |  |
| 14341040 |  | Proc CAMAC Controller & Crate (FAST Electrnc's) | 245d | 2012-01-05 | 2012-12-21 | 9-120M FS+60d | 190d |  |  |  |  | FENKER H | 1 | 1 | HOWARD F |  |  |  |  | 10-069 |  | 11-026 | 11-046 |  |  |  |  |  |  | 07-024 | 08-016 | 09-012 |  |  |  |  |  |  |  |  |  |
| 14341045 |  | Proc NIM Crates (FAST Electrnc's) | 245d | 2012-01-05 | 2012-12-21 | 9-120M FS+60d | 190d |  |  |  |  | FENKER H | 1 | 1 | HOWARD F |  |  |  |  | 10-069 |  | 11-026 | 11-046 |  |  |  |  |  |  | 07-024 | 08-016 | 09-012 |  |  |  |  |  |  |  |  |  |
| 14341050 |  | Proc NIM & CAMAC Logic (FAST Electrnc's) | 245d | 2012-01-05 | 2012-12-21 | 9-120M FS+60d | 190d |  |  |  |  | FENKER H | 1 | 1 | HOWARD F |  |  |  |  | 10-069 |  | 11-026 | 11-046 |  |  |  |  |  |  | 07-024 | 08-016 | 09-012 |  |  |  |  |  |  |  |  |  |
| 14341055 |  | Proc scalers (FAST Electrnc's) | 245d | 2012-01-05 | 2012-12-21 | 9-120M FS+60d | 190d |  |  |  |  | FENKER H | 1 | 1 | HOWARD F |  |  |  |  | 10-069 |  | 11-026 | 11-046 |  |  |  |  |  |  | 07-024 | 08-016 | 09-012 |  |  |  |  |  |  |  |  |  |
| 14341060 |  | Proc Cables & Connectors (FAST Electrnc's) | 245d | 2012-01-05 | 2012-12-21 | 9-120M FS+60d | 190d |  |  | PROCUREMENT<$50K 60 NO ESCALATION FY13 | 5,324.09 | FENKER H | 1 | 1 | HOWARD F |  |  |  |  | 10-069 |  | 11-026 | 11-046 |  |  |  |  |  |  | 07-024 | 08-016 | 09-012 |  |  |  |  |  |  |  |  |  |
| 14341065 |  | Proc VME Crates (FAST Electrnc's) REF. HallD 1544006 | 123d | 2012-01-05 | 2012-06-29 | 9-120M FS+60d | 71.5d | 0d |  | PROCUREMENT<$50K 60 | 10,648.18 | FENKER H | 1 | 1 | HOWARD F |  |  |  |  | 10-069 | 11-025 | 11-026 | 11-046 |  |  |  |  |  |  | 07-024 | 08-016 | 09-012 | 12-012 |  |  |  |  |  |  |  |  |
| 14341070 |  | Proc High-Power 21-slot VME64x/VXS crate for DF2 | 245d | 2012-01-05 | 2012-12-21 | 9-120M FS+60d | 190d |  |  | PROCUREMENT<$50K 60 NO ESCALATION FY13 | 10,000 | FENKER H | 1 | 1 | HOWARD F |  |  |  |  | 10-069 |  | 11-026 | 11-046 |  |  |  |  |  |  | 07-024 | 08-016 | 09-012 | 12-012 |  |  |  |  |  |  |  |  |
| 14341075 |  | Proc 2 single-board PC's for DCs, Hodoscopes, Cerenkovs for DF2 | 245d | 2012-01-05 | 2012-12-21 | 9-120M FS+60d | 190d |  |  | PROCUREMENT<$50K 60 NO ESCALATION FY13 | 7,000 | FENKER H | 1 | 1 | HOWARD F |  |  |  |  | 10-069 |  | 11-026 | 11-046 |  |  |  |  |  |  | 07-024 | 08-016 | 09-012 | 12-012 |  |  |  |  |  |  |  |  |
| 14341090 |  | Proc SD Module for DF2 | 245d | 2012-01-05 | 2012-12-21 | 9-120M FS+60d | 190d |  |  | PROCUREMENT<$50K 60 NO ESCALATION FY13 | 2,500 | FENKER H | 1 | 1 | HOWARD F |  |  |  |  | 10-069 |  | 11-026 | 11-046 |  |  |  |  |  |  | 07-024 | 08-016 | 09-012 | 12-012 |  |  |  |  |  |  |  |  |
| 14341095 |  | Proc 2 TI Modules for DF2 | 245d | 2012-01-05 | 2012-12-21 | 9-120M FS+60d | 190d |  |  | PROCUREMENT<$50K 60 NO ESCALATION FY13 | 6,450 | FENKER H | 1 | 1 | HOWARD F |  |  |  |  | 10-069 |  | 11-026 | 11-046 |  |  |  |  |  |  | 07-024 | 08-016 | 09-012 | 12-012 |  |  |  |  |  |  |  |  |
| 14341097 |  | Proc TD Module for DF2 | 245d | 2012-01-05 | 2012-12-21 | 9-120M FS+60d | 190d |  |  | PROCUREMENT<$50K 60 NO ESCALATION FY13 | 5,100 | FENKER H | 1 | 1 | HOWARD F |  |  |  |  | 10-069 |  | 11-026 | 11-046 |  |  |  |  |  |  | 07-024 | 08-016 | 09-012 | 12-012 |  |  |  |  |  |  |  |  |
| 14341110 |  | Proc positive high-voltage modules | 245d | 2012-01-05 | 2012-12-21 | 9-120M FS+60d | 190d |  |  | PROCUREMENT<$50K 60 NO ESCALATION FY13 | 10,000 | FENKER H | 1 | 1 | HOWARD F |  |  |  |  | 10-069 |  | 11-026 | 11-046 |  |  |  |  |  |  | 07-024 | 08-016 | 09-012 | 12-012 |  |  |  |  |  |  |  |  |
| 14341115 |  | Recondition 1 existing VME64x crate (w/o VXS) FY12 | 187d | 2012-01-05 | 2012-09-28 | 9-120M FS+60d | 190d | 0d |  | SCIENTIST [44.27 h]; ELEC ENG [42.74 h] | 6,141.63 | FENKER H | 1 | 1 | HOWARD F |  |  |  |  | 10-069 |  | 11-026 | 11-046 |  |  |  |  |  |  | 07-024 | 08-016 | 09-012 | 12-012 |  |  | 12-053 |  |  |  |  |  |
| 14341067 |  | Assemble and Test VME Crates (FAST Electrnc's) REF. HallD 1544025 | 32.5d | 2012-07-02 | 2012-08-15 | 14341065 | 71.5d | 51.5d |  | SCIENTIST [40 h] | 2,824.4 | FENKER H | 1 | 1 | HOWARD F |  |  |  |  | 10-069 | 11-025 | 11-026 | 11-046 |  |  |  |  |  |  | 07-024 | 08-016 | 09-012 | 12-012 |  |  |  |  |  |  |  |  |
| 14341020a |  | Proc ADCs for Calorimeter (FAST Electrnc's) FY13 | 58d | 2012-10-01 | 2012-12-21 | 14341020 | 190d |  |  | SUPPLIES & MATERIALS | 520.24 | FENKER H | 1 | 1 | HOWARD F |  |  |  |  | 10-069 |  | 11-026 | 11-046 |  |  |  |  |  |  | 07-024 | 08-016 | 09-012 |  |  | DUP | 12-053 |  |  |  |  |  |
| 14341100 |  | Proc SSP Module for DF2 | 228d | 2012-10-01 | 2013-08-30 | 9-130M | 20d |  |  | PROCUREMENT<$50K 60 |  | FENKER H | 1 | 1 | HOWARD F | 13-014 |  |  |  | 10-069 |  | 11-026 | 11-046 | 12-022 |  |  |  |  |  | 07-024 | 08-016 | 09-012 | 12-012 |  |  |  |  |  |  |  |  |
| 14341105 |  | Proc 11 TDC modules with CAEN 1190 specs for DC, Cerenkovs, Hodoscopes - for DF2 | 228d | 2012-10-01 | 2013-08-30 | 9-130M | 20d |  |  | PROCUREMENT>$50K 69; PROCUREMENT<$50K 60 |  | FENKER H | 1 | 1 | HOWARD F | 13-014 |  |  |  | 10-069 |  | 11-026 | 11-046 | 12-022 | 13-006 |  |  |  |  | 07-024 | 08-016 | 09-012 | 12-012 |  |  |  |  |  |  |  |  |
| 14341115a |  | Recondition 1 existing VME64x crate (w/o VXS) FY13 | 58d | 2012-10-01 | 2012-12-21 | 14341115 | 190d |  |  | SCIENTIST [13.73 h]; ELEC ENG [13.26 h] | 1,965.83 | FENKER H | 1 | 1 | HOWARD F |  |  |  |  | 10-069 |  | 11-026 | 11-046 |  |  |  |  |  |  | 07-024 | 08-016 | 09-012 | 12-012 |  |  | 12-053 |  |  |  |  |  |
| 14341000 |  | DAQ Trigger Development | 208d | 2012-10-29 | 2013-08-30 | 14341067, 9-130M FS+20d | 20d |  |  | SCIENTIST [453.82 h] | 33,065.33 | FENKER H | 1 | 1 | HOWARD F | 13-014 |  |  |  | 10-069 | 11-025 | 11-026 | 11-046 |  |  |  |  |  |  |  |  |  | 12-012 |  |  |  | 12-054 |  |  |  |  |
| 14341120 |  | Re-Baseline Actuals Adjustment | 1d | 2013-08-30 | 2013-08-30 | 9-130M FS+227d | 20d |  |  | PROCUREMENT>$50K 69 NO ESCALATION | 91,554.55 | FENKER H | 1 | 1 | HOWARD F | 13-014 | ADJ |  |  |  |  |  |  |  |  |  |  |  |  |  |  |  |  |  |  |  |  |  |  |  |  |
| 24341000 |  | DAQ Trigger Development FY13 | 20d | 2013-09-03 | 2013-09-30 | 9-130M FS+228d | 317d | 0d | 8/5 M-F w/JLAB Holidays ReBaseline | SCIENTIST [46.15 h] | 3,362.49 | FENKER H | 1 | 1 | HOWARD F |  |  | 24341000 | S | 10-069 | 11-025 | 11-026 | 11-046 |  | 13-006F |  | 13-015 | PR |  |  |  |  | 12-012 |  |  |  | 12-054 | ST | PE |  |  |
| 24341085 |  | Proc CTP Module for DF2 | 43d | 2013-09-03 | 2013-10-31 | 9-130M FS+228d | 378d | 192d | 8/5 M-F w/JLAB Holidays ReBaseline | PROCUREMENT>$50K 69 NO ESCALATION FY14; PROCUREMENT<$50K 60 NO ESCALATION FY14 | 5,180.91 | FENKER H | 1 | 1 | HOWARD F |  |  | 24341085 | D | 10-069 |  | 11-026 | 11-046 | 12-022 | 13-006F | EV | 13-015 | PR |  | 07-024 | 08-016 | 09-012 | 12-012 |  |  |  |  |  |  | y | OB |
| 24341000a |  | DAQ Trigger Development FY14 | 84d | 2013-10-01 | 2014-02-10 | 9-130M FS+228d, 24341000 | 317d | 131d | 8/5 M-F w/JLAB Holidays ReBaseline | SCIENTIST [193.85 h] | 14,573.64 | FENKER H | 1 | 1 | HOWARD F |  |  | 24341000 | S | 10-069 | 11-025 | 11-026 | 11-046 |  | 13-006F |  | 13-015 | PR | 14-001 |  |  |  | 12-012 |  |  |  | 12-054 | ST | PE |  |  |

Notes:
- 24341000: Steps: Establish multi-crate readout using new-VXS TS and TI units; Establish multi-crate readout with VXS, VME, and FASTBUS units that we will use in phase-I experiments; Establish verified inventory of all needed DAQ hardware for complete trigger.
- 24341000a: Steps: Establish multi-crate readout using new-VXS TS and TI units; Establish multi-crate readout with VXS, VME, and FASTBUS units that we will use in phase-I experiments; Establish verified inventory of all needed DAQ hardware for complete trigger.

| ID | WBS | Activity | Duration | Start | Finish | Predecessors | Total float | Free float | Calendar | Resources | Cost | RESP - Responsibility | STRT%COMP for CM EVM | FNSH%COMP for CM EVM | CR 07-024 | CAM RESPONSIBLE | Duplications | CR 09-012 | CR 09-022 | CR 10-069 | CR 10-076 | CR 11-026 | CR 12-012 | CR 12-036 | CR 08-016 | CR 13-014 | ReBaseline Actuals Adjustment | Original Activity ID Rebaseline | EVMS Reporting Codes | CR 13-006 | BOE Procurement | CR 13-015 | Post Rebaseline | CR 14-001 | CR 11-046 | CR 12-022 | BOE Labor | BOE Expenses | CR 11-025 | CR 12-053 | CR 12-054 |
| --- | --- | --- | --- | --- | --- | --- | --- | --- | --- | --- | --- | --- | --- | --- | --- | --- | --- | --- | --- | --- | --- | --- | --- | --- | --- | --- | --- | --- | --- | --- | --- | --- | --- | --- | --- | --- | --- | --- | --- | --- | --- |
|  | 2 | **1.4.3.4.2 POWER SUPPLIES & PROBES (Power Supply Infrastructure)** |  | 2010-11-12 | 2014-01-02 |  |  |  |  |  |  |  |  |  |  |  |  |  |  |  |  |  |  |  |  |  |  |  |  |  |  |  |  |  |  |  |  |  |  |  |  |
| 14342005 |  | Proc 4 Pwr Supplies for 480V (PWR SUP) | 1d | 2010-11-12 | 2010-11-12 | 9-110M FS+30d | 707d | 0d |  |  |  | FENKER H | 1 | 1 | 07-024 | HOWARD F | DUP | 09-012 | 09-022 | 10-069 | 10-076 | 11-026 | 12-012 | 12-036F |  |  |  |  |  |  |  |  |  |  |  |  |  |  |  |  |  |
| 14342010 |  | Proc LCW Sys for Pwr Supplies (PWR SUP) | 1d | 2010-11-15 | 2010-11-15 | 14342005 | 707d | 0d |  |  |  | FENKER H | 1 | 1 | 07-024 | HOWARD F | DUP | 09-012 | 09-022 | 10-069 | 10-076 | 11-026 | 12-012 | 12-036F |  |  |  |  |  |  |  |  |  |  |  |  |  |  |  |  |  |
| 14342020 |  | Proc 5000A Rigid Water Cooled Bus (PWR SUP) | 1d | 2010-11-16 | 2010-11-16 | 14342010 | 707d | 257d |  |  |  | FENKER H | 1 | 1 | 07-024 | HOWARD F | DUP | 09-012 | 09-022 | 10-069 | 10-076 | 11-026 | 12-012 | 12-036F | 08-016 |  |  |  |  |  |  |  |  |  |  |  |  |  |  |  |  |
| 14342030 |  | Proc 5000A Flexible Lines (PWR SUP) | 1d | 2011-12-02 | 2011-12-02 | 9-120M FS+42d, 14342020 | 450d | 0d |  |  |  | FENKER H | 1 | 1 | 07-024 | HOWARD F | DUP | 09-012 | 09-022 | 10-069 | 10-076 | 11-026 | 12-012 | 12-036F |  |  |  |  |  |  |  |  |  |  |  |  |  |  |  |  |  |
| 14342035 |  | Fab Stand for Pwr Supplies (PWR SUP) | 1d | 2011-12-02 | 2011-12-02 | 9-120M FS+42d, 14342005 | 450d | 0d |  |  |  | FENKER H | 1 | 1 | 07-024 | HOWARD F | DUP |  | 09-022 | 10-069 | 10-076 | 11-026 | 12-012 | 12-036F |  |  |  |  |  |  |  |  |  |  |  |  |  |  |  |  |  |
| 14342040 |  | Fab Catwalk (PWR SUP) | 1d | 2011-12-05 | 2011-12-05 | 14342030, 14342035 | 450d | 0d |  |  |  | FENKER H | 1 | 1 | 07-024 | HOWARD F | DUP |  | 09-022 | 10-069 | 10-076 | 11-026 | 12-012 | 12-036F |  |  |  |  |  |  |  |  |  |  |  |  |  |  |  |  |  |
| 14342045 |  | Fab Cable Tray & Bus Supprt (PWR SUP) | 1d | 2011-12-06 | 2011-12-06 | 14342040 | 450d |  |  |  |  | FENKER H | 1 | 1 | 07-024 | HOWARD F | DUP | 09-012 | 09-022 | 10-069 | 10-076 | 11-026 | 12-012 | 12-036F |  |  |  |  |  |  |  |  |  |  |  |  |  |  |  |  |  |
| 14342050 |  | Proc 5000A Flexible Lines Revised by 2012 ETC | 120d | 2013-01-03 | 2013-06-24 | 9-130M FS+60d | 68d |  |  | PROCUREMENT>$50K 69; PROCUREMENT<$50K 60 | 61,914 | FENKER H | 1 | 1 | 07-024 | HOWARD F | DUP | 09-012 | 09-022 | 10-069 | 10-076 | 11-026 | 12-012 | 12-036F |  |  |  |  |  |  |  |  |  |  |  |  |  |  |  |  |  |
| 14342060 |  | Re-Baseline Actuals Adjustment | 1d | 2013-08-30 | 2013-08-30 | 9-130M FS+227d | 20d |  |  | PROCUREMENT>$50K 69 NO ESCALATION | -28,650.28 | FENKER H | 1 | 1 |  | HOWARD F |  |  |  |  |  |  |  |  |  | 13-014 | ADJ |  |  |  |  |  |  |  |  |  |  |  |  |  |  |
| 24342055 |  | Fab Cable Tray & Bus Support | 58d | 2013-10-01 | 2014-01-02 | 9-140M | 294d | 49d | 8/5 M-F w/JLAB Holidays ReBaseline | PROCUREMENT<$50K 60 | 26,620.44 | FENKER H | 1 | 1 | 07-024 | HOWARD F | DUP | 09-012 | 09-022 | 10-069 | 10-076 | 11-026 | 12-012 | 12-036F |  |  |  | 24342055 | D | 13-006 | EJ | 13-015 | PR | 14-001 |  |  |  |  |  |  |  |
|  | 5 | **1.4.3.5 BEAMLINE** |  | 2011-01-05 | 2015-05-01 |  |  |  |  |  |  |  |  |  |  |  |  |  |  |  |  |  |  |  |  |  |  |  |  |  |  |  |  |  |  |  |  |  |  |  |  |
|  | 1 | **1.4.3.5.1 MOELLER POLARIMETER** |  | 2012-05-14 | 2014-03-31 |  |  |  |  |  |  |  |  |  |  |  |  |  |  |  |  |  |  |  |  |  |  |  |  |  |  |  |  |  |  |  |  |  |  |  |  |
| 14351005 |  | Proc Pwr Supply for Additional quad for Moeller polarimeter | 130d | 2012-05-14 | 2012-11-14 | 9-100M, 2-02M | 215d |  |  |  |  | FENKER H | 1 | 1 |  | HOWARD F |  |  |  | 10-069 |  | 11-026 |  |  |  |  |  |  |  | 13-006F |  |  |  |  | 11-046 |  |  |  |  |  |  |
| 14351010 |  | Proc Cables/Stand for Additional quad for Moeller polarimeter | 40d | 2013-05-01 | 2013-06-26 | 2-02M, 9-100M, 9-130M FS+142d | 65d | 0d |  | PROCUREMENT<$50K 60 | 7,847.63 | FENKER H | 1 | 1 |  | HOWARD F |  |  |  | 10-069 |  | 11-026 |  |  |  |  |  |  |  | 13-006F |  |  |  |  | 11-046 | 12-022 |  |  |  |  |  |
| 14351020 |  | Modify Moeller Collimator- Manufacturing Drawings | 20d | 2013-05-01 | 2013-05-29 | 2-02M, 9-130M FS+142d | 641d |  |  | SCIENTIST; PROCUREMENT<$50K 60 NO ESCALATION FY14; MECH DES [160 h] | 7,953.6 | FENKER H | 1 | 1 |  | HOWARD F |  |  |  | 10-069 |  | 11-026 |  |  |  |  |  |  |  | 13-006 |  |  |  |  |  | 12-022 |  |  |  |  |  |
| 14351025 |  | Re-Baseline Actuals Adjustment | 1d | 2013-08-30 | 2013-08-30 | 9-130M FS+227d | 20d |  |  | PROCUREMENT>$50K 69 NO ESCALATION | -15,801.23 | FENKER H | 1 | 1 |  | HOWARD F |  |  |  |  |  |  |  |  |  | 13-014 | ADJ |  |  |  |  |  |  |  |  |  |  |  |  |  |  |
| 24351020 |  | Modify Moeller Collimator- Manufacturing Drawings | 65d | 2013-10-18 | 2014-01-31 | 9-140M FS+13d | 468d | 0d | 8/5 M-F w/JLAB Holidays ReBaseline | MECH DES [160 h] | 8,208 | FENKER H | 1 | 1 |  | HOWARD F |  |  |  | 10-069 |  | 11-026 |  |  |  |  |  | 24351020 | H | 13-006 | EJ | 13-015 | PR | 14-001 |  | 12-022 | EJ |  |  |  |  |
| 24351030 |  | Modify Moeller Collimator - FAB/PROCURE | 41d | 2014-02-03 | 2014-03-31 | 9-140M, 24351020 | 526d | 52d | 8/5 M-F w/JLAB Holidays ReBaseline | MECH DES [80 h]; MECH TECH [56 h]; MSHOP; PROCUREMENT<$50K 60 | 41,112.06 | FENKER H | 1 | 1 |  | HOWARD F |  |  |  |  |  |  |  |  |  |  |  | 24351030 | D | 13-006 | EJ | 13-015 | PR | 14-001 |  |  | EJ | EJ |  |  |  |
|  | 2 | **1.4.3.5.2 COMPTON POLARIMETER** |  | 2012-01-20 | 2013-08-30 |  |  |  |  |  |  |  |  |  |  |  |  |  |  |  |  |  |  |  |  |  |  |  |  |  |  |  |  |  |  |  |  |  |  |  |  |
| 14352005 |  | Procure QR Magnets for Compton | 82d | 2012-01-20 | 2012-05-15 | 9-120M FS+70d | 846d | 0d |  |  |  | FENKER H | 1 | 1 |  | HOWARD F |  |  |  | 10-069 |  | 11-026 |  |  |  |  |  |  |  |  |  |  |  |  | 11-046 |  |  |  |  |  |  |
| 14352000 |  | Produce Compton Elevation Layout FY12 | 97d | 2012-05-14 | 2012-09-28 | 9-120M FS+150d | 245d | 0d |  | MECH DES [310.4 h] | 14,951.97 | FENKER H | 1 | 1 |  | HOWARD F |  |  |  | 10-069 |  | 11-026 | 12-012 |  |  |  |  |  |  |  |  |  |  |  | 11-046 |  |  |  | 11-025 | 12-053 | 12-054F |
| 14352000a |  | Produce Compton Elevation Layout FY13 | 3d | 2012-10-01 | 2012-10-03 | 14352000 | 245d |  |  | MECH DES [9.6 h] | 477.22 | FENKER H | 1 | 1 |  | HOWARD F |  |  |  | 10-069 |  | 11-026 | 12-012 |  |  |  |  |  |  |  |  |  |  |  | 11-046 |  |  |  | 11-025 | 12-053 | 12-054F |
| 14352010 |  | Re-Baseline Actuals Adjustment | 1d | 2013-08-30 | 2013-08-30 | 9-130M FS+227d | 20d |  |  | PROCUREMENT>$50K 69 NO ESCALATION | -6,416.3 | FENKER H | 1 | 1 |  | HOWARD F |  |  |  |  |  |  |  |  |  | 13-014 | ADJ |  |  |  |  |  |  |  |  |  |  |  |  |  |  |

| ID | WBS | Activity | Duration | Start | Finish | Predecessors | Total float | Free float | Calendar | Resources | Cost | RESP - Responsibility | STRT%COMP for CM EVM | FNSH%COMP for CM EVM | CR 08-016 | CAM RESPONSIBLE | CR 09-012 | CR 09-022 | CR 10-069 | CR 11-026 | CR 11-046 | CR 12-012 | CR 13-006 | CR 10-025 | CR 12-022 | CR 13-014 | ReBaseline Actuals Adjustment | Original Activity ID Rebaseline | EVMS Reporting Codes | BOE Procurement | BOE Labor | CR 13-015 | Post Rebaseline | CR 14-001 | BOE Expenses | CR 12-001 |
| --- | --- | --- | --- | --- | --- | --- | --- | --- | --- | --- | --- | --- | --- | --- | --- | --- | --- | --- | --- | --- | --- | --- | --- | --- | --- | --- | --- | --- | --- | --- | --- | --- | --- | --- | --- | --- |
|  | 3 | **1.4.3.5.3 MAPPING** |  | 2013-04-01 | 2014-04-30 |  |  |  |  |  |  |  |  |  |  |  |  |  |  |  |  |  |  |  |  |  |  |  |  |  |  |  |  |  |  |  |
| 14353015 |  | Refurb Existing Harmonic Coil for SHMS Mags | 100d | 2013-04-01 | 2013-08-20 | 9-130M FS+120d | 28d |  |  | PROCUREMENT<$50K 60; MECH DES [200 h]; ELEC TECH [200 h]; SCIENTIST [160 h]; TRAVEL; MECH ENG [200 h]; SUPPLIES & MATERIALS; MSHOP | 121,929.52 | FENKER H | 1 | 1 | 08-016 | HOWARD F | 09-012 | 09-022 | 10-069 | 11-026 | 11-046 | 12-012 | 13-006 |  |  |  |  |  |  |  |  |  |  |  |  |  |
| 14353010 |  | Fabricate and Use New ARC Mapper | 48d | 2013-06-25 | 2013-08-30 | 9-130M FS+180d | 573d |  |  | MECH ENG; PROCUREMENT<$50K 60; SCIENTIST [288 h]; ELEC TECH; MECH DES; MECH TECH [320 h] | 35,658.88 | FENKER H | 1 | 1 |  | HOWARD F |  | 09-022 | 10-069 | 11-026 | 11-046 | 12-012 | 13-006 | 10-025 | 12-022 | 13-014 |  |  |  |  |  |  |  |  |  |  |
| 14353020 |  | Re-Baseline Actuals Adjustment | 1d | 2013-08-30 | 2013-08-30 | 9-130M FS+227d | 20d |  |  | PROCUREMENT>$50K 69 NO ESCALATION | -157,588.4 | FENKER H | 1 | 1 |  | HOWARD F |  |  |  |  |  |  |  |  |  | 13-014 | ADJ |  |  |  |  |  |  |  |  |  |
| 24353010 |  | Fabricate and Use New ARC Mapper FY13 | 20d | 2013-09-03 | 2013-09-30 | 9-130M FS+228d | 494d | 0d | 8/5 M-F w/JLAB Holidays ReBaseline | SCIENTIST [93.51 h]; MECH TECH [103.89 h] | 11,577.4 | FENKER H | 1 | 1 |  | HOWARD F |  | 09-022 | 10-069 | 11-026 | 11-046 | 12-012 | 13-006F | 10-025 | 12-022 |  |  | 24353010 | U | EJ | EJ | 13-015 | PR |  |  |  |
| 24353010a |  | Fabricate and Use New ARC Mapper FY14 | 57d | 2013-10-01 | 2013-12-20 | 9-130M FS+228d, 24353010 | 494d |  | 8/5 M-F w/JLAB Holidays ReBaseline | SCIENTIST [266.49 h]; MECH TECH [296.11 h] | 34,046.77 | FENKER H | 1 | 1 |  | HOWARD F |  | 09-022 | 10-069 | 11-026 | 11-046 | 12-012 | 13-006F | 10-025 | 12-022 |  |  | 24353010 | U | EJ | EJ | 13-015 | PR | 14-001 |  |  |
| 24353015 |  | Refurb Existing Harmonic Coil for SHMS Mags | 75d | 2014-01-15 | 2014-04-30 | 9-140M FS+66d | 370d | 81d | 8/5 M-F w/JLAB Holidays ReBaseline | MECH TECH [16 h]; PROCUREMENT<$50K 60; MECH DES [200 h]; ELEC TECH [200 h]; SCIENTIST [160 h]; TRAVEL; MECH ENG [200 h]; SUPPLIES & MATERIALS; MSHOP | 126,576.16 | FENKER H | 1 | 1 | 08-016 | HOWARD F | 09-012 | 09-022 | 10-069 | 11-026 | 11-046 | 12-012 | 13-006 |  |  |  |  | 24353015 | U | EJ | EJ | 13-015 | PR | 14-001 | EJ |  |
|  | 4 | **1.4.3.5.4 SCATTERING CHAMBER** |  | 2011-01-05 | 2014-09-05 |  |  |  |  |  |  |  |  |  |  |  |  |  |  |  |  |  |  |  |  |  |  |  |  |  |  |  |  |  |  |  |
| 14354005 |  | Modify Existing Chamb Cylinder (SCATTER CHAMB) | 65d | 2011-01-05 | 2011-04-07 | 9-110M FS+60d | 417d | 0d |  | MECH TECH [80 h]; TRAVEL; PROCUREMENT<$50K 60; MECH ENG [40 h] | 43,310.8 | FENKER H | 1 | 1 | 08-016 | HOWARD F | 09-012 | 09-022 | 10-069 | 11-026 | 11-046 | 12-012 | 13-006F |  | 12-022 |  |  |  |  |  |  |  |  |  |  |  |
| 14354010 |  | Proc & Install Chamb Flanges (SCATTER CHAMB) | 80d | 2011-04-08 | 2011-08-01 | 9-110M, 14354005, 14354008 FS-600d | 417d | 0d |  | MECH ENG [40 h]; MECH TECH [40 h] | 4,440.8 | FENKER H | 1 | 1 |  | HOWARD F |  | 09-022 | 10-069 | 11-026 | 11-046 | 12-012 | 13-006F |  | 12-022 |  |  |  |  |  |  |  |  |  |  |  |
| 14354015 |  | Proc & Install HMS & SHMS Window Frames (SCATTER CHAMB) FY11 | 43d | 2011-08-02 | 2011-09-30 | 14354010 | 417d | 0d |  | MECH ENG [21.5 h]; MECH TECH [86 h]; MECH DES [43 h] | 7,172.19 | FENKER H | 1 | 1 |  | HOWARD F |  | 09-022 | 10-069 | 11-026 | 11-046 | 12-012 | 13-006F |  | 12-022 |  |  |  |  |  |  |  |  |  |  | 12-001 |
| 14354015a |  | Proc & Install HMS & SHMS Window Frames (SCATTER CHAMB) FY12 | 37d | 2011-10-03 | 2011-11-22 | 14354015 | 417d | 0d |  | MECH TECH [74 h]; MECH DES [37 h]; MECH ENG [18.5 h] | 6,368.07 | FENKER H | 1 | 1 |  | HOWARD F |  | 09-022 | 10-069 | 11-026 | 11-046 | 12-012 | 13-006F |  | 12-022 |  |  |  |  |  |  |  |  |  |  | 12-001 |
| 14354020 |  | Proc & Install HMS & SHMS Blank Covers (SCATTER CHAMB) | 20d | 2011-11-23 | 2011-12-29 | 14354015a | 417d | 0d |  | MECH DES [160 h] | 7,707.2 | FENKER H | 1 | 1 |  | HOWARD F |  | 09-022 | 10-069 | 11-026 | 11-046 | 12-012 | 13-006F |  | 12-022 |  |  |  |  |  |  |  |  |  |  |  |
| 14354030 |  | Proc & Install Gate Valves,BL adaptors & Vac Gauges (SCATTER CHAMB) Original Labor | 21d | 2011-12-30 | 2012-01-31 | 14354020 | 417d |  |  | SUPPLIES & MATERIALS; TRAVEL; MECH ENG [22.4 h]; PLABOR; MECH TECH [33.6 h]; MECH DES [89.6 h] | 16,746.03 | FENKER H | 1 | 1 | 08-016 | HOWARD F | 09-012 | 09-022 | 10-069 | 11-026 | 11-046 | 12-012 | 13-006F |  | 12-022 |  |  |  |  |  |  |  |  |  |  |  |
| 14354025 |  | Proc Turbo Pump Sys (SCATTER CHAMB) | 130d | 2013-02-01 | 2013-08-06 | 9-130M FS+80d, 14354005 | 38d |  |  | PROCUREMENT<$50K 60 | 44,671.18 | FENKER H | 1 | 1 |  | HOWARD F |  | 09-022 | 10-069 | 11-026 | 11-046 | 12-012 | 13-006F |  | 12-022 |  |  |  |  |  |  |  |  |  |  |  |
| 14354008 |  | Proc & Fab Chamb Flanges (SCATTER CHAMB) | 80d | 2013-04-15 | 2013-08-06 | 9-130M FS+130d | 437d | 20d |  | MSHOP | 10,000 | FENKER H | 1 | 1 |  | HOWARD F |  |  |  |  |  |  | 13-006 |  |  |  |  |  |  |  |  |  |  |  |  |  |
| 14354035 |  | Re-Baseline Actuals Adjustment | 1d | 2013-08-30 | 2013-08-30 | 9-130M FS+227d | 20d |  |  | PROCUREMENT>$50K 69 NO ESCALATION | -107,037.97 | FENKER H | 1 | 1 |  | HOWARD F |  |  |  |  |  |  |  |  |  | 13-014 | ADJ |  |  |  |  |  |  |  |  |  |
| 24354008 |  | Proc & Fab Chamb Flanges (SCATTER CHAMB) | 80d | 2014-03-05 | 2014-06-25 | 9-140M FS+100d | 809d | 520d | 8/5 M-F w/JLAB Holidays ReBaseline | MSHOP | 10,319 | FENKER H | 1 | 1 |  | HOWARD F |  |  |  |  |  |  | 13-006 |  |  |  |  | 24354008 | U |  |  | 13-015 | PR | 14-001 | PE |  |
| 24354010 |  | Procure and Install Chamb Flanges (SCATTER CHAMB) | 130d | 2014-03-05 | 2014-09-05 | 24354008 FS-600d, 9-140M FS+100d | 341d | 0d | 8/5 M-F w/JLAB Holidays ReBaseline | MECH ENG [40 h]; MECH TECH [40 h] | 4,879.6 | FENKER H | 1 | 1 |  | HOWARD F |  | 09-022 | 10-069 | 11-026 | 11-046 | 12-012 |  |  | 12-022 |  |  | 24354010 | U |  | PE | 13-015 | PR | 14-001 |  |  |
| 24354015a |  | Proc & Install HMS & SHMS Window Frames (SCATTER CHAMB) | 130d | 2014-03-05 | 2014-09-05 | 24354010 FS-130d, 9-140M FS+100d | 341d | 0d | 8/5 M-F w/JLAB Holidays ReBaseline | MECH TECH [160 h]; MECH DES [80 h]; MECH ENG [40 h] | 14,662 | FENKER H | 1 | 1 |  | HOWARD F |  | 09-022 | 10-069 | 11-026 | 11-046 | 12-012 |  |  | 12-022 |  |  | 24354015a | U |  | PE | 13-015 | PR | 14-001 |  | 12-001 |
| 24354020 |  | Proc & Install HMS & SHMS Blank Covers (SCATTER CHAMB) | 130d | 2014-03-05 | 2014-09-05 | 24354015a FS-130d, 9-140M FS+100d | 341d | 0d | 8/5 M-F w/JLAB Holidays ReBaseline | MECH DES [160 h] | 8,208 | FENKER H | 1 | 1 |  | HOWARD F |  | 09-022 | 10-069 | 11-026 | 11-046 | 12-012 |  |  | 12-022 |  |  | 24354020 | U |  | PE | 13-015 | PR | 14-001 |  |  |
| 24354022 |  | Modify Seal on Scattering Chamber | 120d | 2014-03-05 | 2014-08-21 | 9-140M FS+100d | 321d | 88d | 8/5 M-F w/JLAB Holidays ReBaseline | MECH DES [400 h]; MECH ENG [400 h]; PROCUREMENT<$50K 60 | 60,707 | FENKER H | 1 | 1 |  | HOWARD F |  |  |  |  |  |  | 13-006 |  |  |  |  | 24354022 | S | PE | PE | 13-015 | PR | 14-001 |  |  |
| 24354030 |  | Proc & Install Gate Valves,BL adaptors & Vac Gauges (SCATTER CHAMB) Labor | 75d | 2014-03-05 | 2014-06-18 | 24354020 FS-130d, 9-140M FS+100d | 341d |  | 8/5 M-F w/JLAB Holidays ReBaseline | MECH ENG [80 h]; MECH TECH [120 h]; MECH DES [320 h]; SUPPLIES & MATERIALS; PLABOR; TRAVEL | 46,990.03 | FENKER H | 1 | 1 | 08-016 | HOWARD F | 09-012 | 09-022 | 10-069 | 11-026 | 11-046 | 12-012 | 13-006F |  | 12-022 |  |  | 24354030 | U | EJ | EJ | 13-015 | PR | 14-001 | EJ |  |
| 24354030b |  | Proc & Install Gate Valves,BL adaptors & Vac Gauges (SCATTER CHAMB) Procurement | 75d | 2014-03-05 | 2014-06-18 | 9-140M FS+100d | 341d | 133d | 8/5 M-F w/JLAB Holidays ReBaseline | PROCUREMENT<$50K 60 | 37,375.29 | FENKER H | 1 | 1 | 08-016 | HOWARD F | 09-012 | 09-022 | 10-069 | 11-026 | 11-046 | 12-012 |  |  | 12-022 |  |  | 24354030b | D | EJ |  | 13-015 | PR | 14-001 |  |  |

| ID | WBS | Activity | Type | Duration | Start | Finish | Predecessors | Total float | Free float | Calendar | Resources | Cost | RESP - Responsibility | STRT%COMP for CM EVM | FNSH%COMP for CM EVM | CAM RESPONSIBLE | CR 10-069 | CR 11-026 | CR 11-046 | CR 12-012 | CR 12-054 | CR 13-006 | CR 13-014 | ReBaseline Actuals Adjustment | Original Activity ID Rebaseline | EVMS Reporting Codes | BOE Labor | CR 13-015 | Post Rebaseline | CR 14-001 | BOE Procurement | BOE Expenses | CR 08-016 | CR 09-012 | Milestone Level | CR 08-052 | CR 11-025 | CR 12-036 | Advance Purchase Plan > 500K | 12 GEV MAJOR PROCUREMENT CATAGORY | CR 09-022 | CR 12-001 | BOE NOTES | Over Under Fixed | CR 10-025 | CR 12-055 | Obligated Prior to Rebaseline |
| --- | --- | --- | --- | --- | --- | --- | --- | --- | --- | --- | --- | --- | --- | --- | --- | --- | --- | --- | --- | --- | --- | --- | --- | --- | --- | --- | --- | --- | --- | --- | --- | --- | --- | --- | --- | --- | --- | --- | --- | --- | --- | --- | --- | --- | --- | --- | --- |
|  | 5 | **1.4.3.5.5 BEAM PIPE & STANDS** |  |  | 2013-08-28 | 2015-05-01 |  |  |  |  |  |  |  |  |  |  |  |  |  |  |  |  |  |  |  |  |  |  |  |  |  |  |  |  |  |  |  |  |  |  |  |  |  |  |  |  |  |
| 14355010 |  | Proc 2nd Section of Beam Pipe (Beam Pipe) |  | 3d | 2013-08-28 | 2013-08-30 | 9-130M FS+225d | 20d |  |  | MECH DES [5.54 h]; MECH ENG [1.85 h]; MECH TECH [1.85 h]; PROCUREMENT<$50K 60 NO ESCALATION FY14 | 493.53 | FENKER H | 1 | 1 | HOWARD F | 10-069 | 11-026 | 11-046 | 12-012 | 12-054 | 13-006F | 13-014 |  |  |  |  |  |  |  |  |  |  |  |  |  |  |  |  |  |  |  |  |  |  |  |  |
| 14355015 |  | Proc 3rd Section of Beam Pipe (Beam Pipe) |  | 3d | 2013-08-28 | 2013-08-30 | 9-130M FS+225d | 20d |  |  | MECH ENG [1.85 h]; MECH TECH [1.85 h]; MECH DES [6.46 h]; TRAVEL; PROCUREMENT<$50K 60 NO ESCALATION FY14; PROCUREMENT>$50K 69 NO ESCALATION FY14 | 596.64 | FENKER H | 1 | 1 | HOWARD F | 10-069 | 11-026 | 11-046 | 12-012 | 12-054 | 13-006F | 13-014 |  |  |  |  |  |  |  |  |  |  |  |  |  |  |  |  |  |  |  |  |  |  |  |  |
| 14355035 |  | Re-Baseline Actuals Adjustment |  | 1d | 2013-08-30 | 2013-08-30 | 9-130M FS+227d | 20d |  |  | PROCUREMENT>$50K 69 NO ESCALATION | -1,090.17 | FENKER H | 1 | 1 | HOWARD F |  |  |  |  |  |  | 13-014 | ADJ |  |  |  |  |  |  |  |  |  |  |  |  |  |  |  |  |  |  |  |  |  |  |  |
| 24355000 |  | Produce Manufacturing Drawings for Beam Pipe, Stands, Fittings |  | 65d | 2014-07-01 | 2014-10-01 | 9-140M FS+183d | 270d | 74d | 8/5 M-F w/JLAB Holidays ReBaseline | MECH DES [800 h]; MECH ENG [200 h] | 55,974 | FENKER H | 1 | 1 | HOWARD F |  |  |  |  |  | 13-006 |  |  | 24355000 | S | PE | 13-015 | PR | 14-001 |  |  |  |  |  |  |  |  |  |  |  |  |  |  |  |  |  |
| 24355005 |  | Proc 1st Pipe (Beam Pipe) |  | 58d | 2014-10-01 | 2014-12-23 | 24355000 FS-75d, 9-155M | 196d | 84d | 8/5 M-F w/JLAB Holidays ReBaseline | MECH TECH [80 h]; MECH DES [160 h]; MECH ENG [80 h]; PROCUREMENT<$50K 60 | 32,119.97 | FENKER H | 1 | 1 | HOWARD F | 10-069 | 11-026 | 11-046 | 12-012 | 12-054 |  |  |  | 24355005 | D | EJ | 13-015 | PR | 14-001 | EJ |  |  |  |  |  |  |  |  |  |  |  |  |  |  |  |  |
| 24355010 |  | Proc 2nd Section of Beam Pipe (Beam Pipe) |  | 55d | 2014-11-03 | 2015-02-02 | 9-155M FS+23d | 112d | 0d | 8/5 M-F w/JLAB Holidays ReBaseline | MECH DES [240 h]; MECH ENG [80 h]; MECH TECH [80 h]; PROCUREMENT<$50K 60 | 43,923.28 | FENKER H | 1 | 1 | HOWARD F | 10-069 | 11-026 | 11-046 | 12-012 | 12-054 |  |  |  | 24355010 | D | EJ | 13-015 | PR | 14-001 | EJ |  |  |  |  |  |  |  |  |  |  |  |  |  |  |  |  |
| 24355015 |  | Proc 3rd Section of Beam Pipe (Beam Pipe) |  | 56d | 2014-12-02 | 2015-03-02 | 9-155M FS+42d | 112d | 0d | 8/5 M-F w/JLAB Holidays ReBaseline | MECH ENG [80 h]; MECH TECH [80 h]; MECH DES [280 h]; TRAVEL; PROCUREMENT<$50K 60; PROCUREMENT>$50K 69 | 53,674.59 | FENKER H | 1 | 1 | HOWARD F | 10-069 | 11-026 | 11-046 | 12-012 | 12-054 |  |  |  | 24355015 | D | EJ | 13-015 | PR | 14-001 | EJ | EJ |  |  |  |  |  |  |  |  |  |  |  |  |  |  |  |
| 24355020 |  | Proc Windows & Window Spool (Beam Pipe) |  | 84d | 2015-01-05 | 2015-05-01 | 24355015 FS-40d, 24355010 FS-20d, 24355005 FS-90d | 117d | 5d | 8/5 M-F w/JLAB Holidays ReBaseline | MECH ENG [240 h]; MECH TECH [120 h]; MECH DES [240 h]; PROCUREMENT>$50K 69 | 71,916.07 | FENKER H | 1 | 1 | HOWARD F | 10-069 | 11-026 | 11-046 | 12-012 | 12-054 |  |  |  | 24355020 | D | EJ | 13-015 | PR | 14-001 | EJ |  | 08-016 | 09-012 |  |  |  |  |  |  |  |  |  |  |  |  |  |
| 24355025 |  | Proc Beam Stands (Beam Pipe) |  | 84d | 2015-01-05 | 2015-05-01 | 24355005 FS-90d, 24355010 FS-20d, 24355015 FS-40d | 112d | 0d | 8/5 M-F w/JLAB Holidays ReBaseline | PROCUREMENT<$50K 60 | 18,002.42 | FENKER H | 1 | 1 | HOWARD F | 10-069 | 11-026 | 11-046 | 12-012 | 12-054 |  |  |  | 24355025 | D | EJ | 13-015 | PR | 14-001 | EJ |  | 08-016 | 09-012 |  |  |  |  |  |  |  |  |  |  |  |  |  |
| 24355030 |  | Proc Vac Fittings (Beam Pipe) |  | 84d | 2015-01-05 | 2015-05-01 | 24355025 FS-84d | 122d | 10d | 8/5 M-F w/JLAB Holidays ReBaseline | PROCUREMENT<$50K 60 | 15,037.32 | FENKER H | 1 | 1 | HOWARD F | 10-069 | 11-026 | 11-046 | 12-012 | 12-054 |  |  |  | 24355030 | D | EJ | 13-015 | PR | 14-001 | EJ |  |  |  |  |  |  |  |  |  |  |  |  |  |  |  |  |
|  | 6 | **1.4.3.5.6 MAGNET POWER SUPPLY** |  |  |  |  |  |  |  |  |  |  |  |  |  |  |  |  |  |  |  |  |  |  |  |  |  |  |  |  |  |  |  |  |  |  |  |  |  |  |  |  |  |  |  |  |  |
|  | 6 | **1.4.3.6 INFRASTUCTURE** |  |  | 2009-01-05 | 2015-12-23 |  |  |  |  |  |  |  |  |  |  |  |  |  |  |  |  |  |  |  |  |  |  |  |  |  |  |  |  |  |  |  |  |  |  |  |  |  |  |  |  |  |
|  | 1 | **1.4.3.6.1 ENGINEERING & DESIGN** |  |  |  |  |  |  |  |  |  |  |  |  |  |  |  |  |  |  |  |  |  |  |  |  |  |  |  |  |  |  |  |  |  |  |  |  |  |  |  |  |  |  |  |  |  |
|  | 2 | **1.4.3.6.2 SUPPORT STRUCTURE** |  |  | 2009-11-02 | 2013-09-30 |  |  |  |  |  |  |  |  |  |  |  |  |  |  |  |  |  |  |  |  |  |  |  |  |  |  |  |  |  |  |  |  |  |  |  |  |  |  |  |  |  |
| 14362000M |  | Award Contract to Dsgn the Supprt Struct | milestone | 0d | 2009-11-02 | 2009-11-02 | 12236040, 9-100M FS+22d, 12236830LOE | 296d | 0d |  |  |  | FENKER H | 1 | 1 | HOWARD F | 10-069 | 11-026 | 11-046 | 12-012 |  |  |  |  |  |  |  |  |  |  |  |  |  |  | 6 | 08-052 | 11-025 | 12-036F |  |  |  |  |  |  |  |  |  |
| 14362005 |  | Finalize Dsgn of Supprt Struct |  | 226d | 2009-11-02 | 2010-09-30 | 14362000M | 296d | 0d |  | MECH ENG [184.5 h]; PROCUREMENT<$50K 60; PROCUREMENT>$50K 69; MECH DES [184.5 h] | 71,192.75 | FENKER H | 1 | 1 | HOWARD F | 10-069 | 11-026 | 11-046 | 12-012 |  |  |  |  |  |  |  |  |  |  |  |  | 08-016 | 09-012 |  | 08-052 | 11-025 | 12-036F | APP | 4362B | 09-022 |  |  |  |  |  |  |
| 14362006 |  | SS/SH Engineering Support FY10 |  | 21d | 2010-09-01 | 2010-09-30 | 14362005 FS-21d | 296d | 0d |  | MECH DES [465 h]; MECH ENG [465 h]; PROCUREMENT>$50K 69 | 52,565.9 | FENKER H | 1 | 1 | HOWARD F | 10-069 | 11-026 | 11-046 | 12-012 |  |  |  |  |  |  |  |  |  |  |  |  | 08-016 | 09-012 |  | 08-052 | 11-025 | 12-036F | APP | 4362B | 09-022 |  |  |  |  |  |  |
| 14362007 |  | SS/SH Engineering Support FY11 |  | 248d | 2010-10-01 | 2011-09-30 | 14362006, 9-110M | 296d | 0d |  | PROCUREMENT<$50K 60; PROCUREMENT>$50K 69 | 139,306.5 | FENKER H | 1 | 1 | HOWARD F | 10-069 | 11-026 | 11-046 | 12-012 |  |  |  |  |  |  |  |  |  |  |  |  |  |  |  |  | 11-025 | 12-036F | APP | 4362B |  |  |  |  |  |  |  |
| 14362075 |  | Fab Main Bearing of Supprt Struct Labor FY11 |  | 248d | 2010-10-01 | 2011-09-30 | 14362005 | 381d | 0d |  | MECH DES [79.36 h]; MECH ENG [79.36 h] | 9,097.03 | FENKER H | 1 | 1 | HOWARD F | 10-069 | 11-026 | 11-046 | 12-012 |  | 13-006F |  |  |  |  |  |  |  |  |  |  | 08-016 | 09-012 |  | 08-052 | 11-025 | 12-036F | APP |  | 09-022 | 12-001 |  |  |  |  |  |
| 14362075b |  | Fab Main Bearing of Supprt Struct Procurement |  | 250d | 2010-10-01 | 2011-10-04 | 14362005 | 381d | 361d |  | PROCUREMENT<$50K 60 NO ESCALATION FY12; PROCUREMENT>$50K 69 NO ESCALATION FY12 | 83,903.9 | FENKER H | 1 | 1 | HOWARD F | 10-069 | 11-026 | 11-046 | 12-012 |  | 13-006F |  |  |  |  |  |  |  |  |  |  | 08-016 | 09-012 |  | 08-052 | 11-025 | 12-036F | APP |  | 09-022 | 12-001 |  |  |  |  |  |
| 14362811LOE |  | Overlook Various Subcontracts of Supprt Struct |  | 248d | 2010-10-01 | 2011-09-30 | 9-110M | 1238d | 0d |  | SCIENTIST [200 h] | 13,686 | FENKER H | 1 | 1 | HOWARD F | 10-069 | 11-026 | 11-046 |  |  |  |  |  |  |  |  |  |  |  |  |  |  |  |  | 08-052 |  |  |  |  | 09-022 |  |  |  |  |  |  |
| 14362010M |  | Review Final Dsgn of Supprt Struct | milestone | 0d | 2010-10-27 | 2010-10-27 | 14362005, 14362006 FS+19d, 14363010 | 306d | 0d |  |  |  | FENKER H | 1 | 1 | HOWARD F | 10-069 | 11-026 | 11-046 | 12-012 |  | 13-006F |  |  |  |  |  |  |  |  |  |  |  |  | 6 | 08-052 | 11-025 | 12-036F |  |  |  |  |  |  |  |  |  |
| 14362046a |  | Produce Drawings - Wheels |  | 23d | 2010-10-28 | 2010-12-01 | 14362010M | 306d | 0d |  | MECH ENG [200 h]; MECH DES [400 h] | 32,262 | FENKER H | 1 | 1 | HOWARD F | 10-069 | 11-026 | 11-046 | 12-012 |  | 13-006F |  |  |  |  |  |  |  |  |  |  | 08-016 | 09-012 |  | 08-052 | 11-025 | 12-036F | APP | 4362C | 09-022 |  |  |  |  |  |  |
| 14362012 |  | Produce Drawings - Rails & Base of Supprt Struct |  | 19d | 2010-12-02 | 2011-01-05 | 14362046a | 306d | 0d |  | MECH DES [320 h]; MECH ENG [160 h] | 25,809.6 | FENKER H | 1 | 1 | HOWARD F | 10-069 | 11-026 | 11-046 | 12-012 |  | 13-006F |  |  |  |  |  |  |  |  |  |  |  |  |  | 08-052 | 11-025 | 12-036F | APP |  | 09-022 |  |  |  |  |  |  |
| 14362046 |  | Produce Drawings - Bogies |  | 23d | 2010-12-02 | 2011-01-11 | 14362046a | 347d | 0d |  | MECH DES [400 h]; MECH ENG [200 h] | 32,262 | FENKER H | 1 | 1 | HOWARD F | 10-069 | 11-026 | 11-046 | 12-012 | 12-054F | 13-006F |  |  |  |  |  |  |  |  |  |  | 08-016 | 09-012 |  | 08-052 | 11-025 | 12-036F | APP | 4362C | 09-022 |  |  |  |  |  |  |
| 14362047a |  | Procurement Prep - Wheels |  | 20d | 2010-12-02 | 2011-01-06 | 14362046a, 9-110M | 424d | 186d |  | MECH ENG [80 h] | 5,436 | FENKER H | 1 | 1 | HOWARD F | 10-069 | 11-026 | 11-046 | 12-012 |  | 13-006F |  |  |  |  |  |  |  |  |  |  | 08-016 | 09-012 |  | 08-052 | 11-025 | 12-036F | APP | 4362C | 09-022 |  |  |  |  |  |  |
| 14362016 |  | Produce Drawings - Pivot Sections of Supprt Struct |  | 20d | 2011-01-06 | 2011-02-03 | 14362012 | 306d | 0d |  | MECH ENG [160 h]; MECH DES [320 h] | 25,809.6 | FENKER H | 1 | 1 | HOWARD F | 10-069 | 11-026 | 11-046 | 12-012 |  | 13-006F |  |  |  |  |  |  |  |  |  |  |  |  |  | 08-052 | 11-025 | 12-036F | APP | 4362A | 09-022 |  |  |  |  |  |  |
| 14362047 |  | Procurement Prep - Bogies |  | 20d | 2011-01-12 | 2011-02-09 | 14362046, 9-110M | 347d | 0d |  | MECH ENG [80 h] | 5,436 | FENKER H | 1 | 1 | HOWARD F | 10-069 | 11-026 | 11-046 | 12-012 | 12-054F | 13-006F |  |  |  |  |  |  |  |  |  |  | 08-016 | 09-012 |  | 08-052 | 11-025 | 12-036F | APP | 4362C | 09-022 |  |  |  |  |  |  |
| 14362041 |  | Produce Drawings - Access Platforms of Supprt Struct |  | 21d | 2011-02-04 | 2011-03-07 | 14362016 | 306d | 0d |  | MECH ENG [160 h]; MECH DES [320 h] | 25,809.6 | FENKER H | 1 | 1 | HOWARD F | 10-069 | 11-026 | 11-046 | 12-012 |  | 13-006F |  |  |  |  |  |  |  |  |  |  | 08-016 | 09-012 |  | 08-052 | 11-025 | 12-036F | APP |  | 09-022 |  |  |  |  |  |  |
| 14362013 |  | Procurement Prep - Rails & Base of Supprt Struct |  | 18d | 2011-02-10 | 2011-03-08 | 14362047, 14362012 | 347d | 0d |  | MECH ENG [80 h] | 5,436 | FENKER H | 1 | 1 | HOWARD F | 10-069 | 11-026 | 11-046 | 12-012 | 12-054F | 13-006F |  |  |  |  |  |  |  |  |  |  |  |  |  | 08-052 | 11-025 | 12-036F | APP |  | 09-022 |  |  |  |  |  |  |
| 14362036 |  | Produce Drawings - Mag Mounts of Supprt Struct |  | 21d | 2011-03-08 | 2011-04-05 | 14362041 | 306d | 0d |  | MECH DES [320 h]; MECH ENG [160 h] | 25,809.6 | FENKER H | 1 | 1 | HOWARD F | 10-069 | 11-026 | 11-046 | 12-012 |  | 13-006F |  |  |  |  |  |  |  |  |  |  |  |  |  | 08-052 | 11-025 | 12-036F | APP |  | 09-022 |  |  |  |  |  |  |
| 14362017 |  | Procurement Prep - Pivot Sections of Supprt Struct |  | 20d | 2011-03-09 | 2011-04-05 | 14362013, 14362016 | 374d | 0d |  | MECH ENG [80 h] | 5,436 | FENKER H | 1 | 1 | HOWARD F | 10-069 | 11-026 | 11-046 | 12-012 |  | 13-006F |  |  |  |  |  |  |  |  |  |  |  |  |  | 08-052 | 11-025 | 12-036F | APP | 4362A | 09-022 |  |  |  |  |  |  |
| 14362026 |  | Produce Drawings - Detector Section of Supprt Struct |  | 19d | 2011-04-06 | 2011-05-02 | 14362036 | 306d | 0d |  | MECH DES [320 h]; MECH ENG [160 h] | 25,809.6 | FENKER H | 1 | 1 | HOWARD F | 10-069 | 11-026 | 11-046 | 12-012 |  | 13-006F |  |  |  |  |  |  |  |  |  |  | 08-016 | 09-012 |  | 08-052 | 11-025 | 12-036F | APP |  | 09-022 |  |  |  |  |  |  |
| 14362042 |  | Procurement Prep - Access Platforms of Supprt Struct |  | 20d | 2011-04-06 | 2011-05-03 | 14362041, 14362017 | 374d | 0d |  | MECH ENG [80 h] | 5,436 | FENKER H | 1 | 1 | HOWARD F | 10-069 | 11-026 | 11-046 | 12-012 |  | 13-006F |  |  |  |  |  |  |  |  |  |  | 08-016 | 09-012 |  | 08-052 | 11-025 | 12-036F | APP |  | 09-022 |  |  |  |  |  |  |
| 14362027 |  | Procurement Prep - Detector Section of Supprt Struct |  | 19d | 2011-05-03 | 2011-05-27 | 14362026 | 318d | 4d |  | MECH ENG [80 h] | 5,436 | FENKER H | 1 | 1 | HOWARD F | 10-069 | 11-026 | 11-046 | 12-012 |  | 13-006F |  |  |  |  |  |  |  |  |  |  | 08-016 | 09-012 |  | 08-052 | 11-025 | 12-036F | APP |  | 09-022 |  |  |  |  |  |  |
| 14362051 |  | Produce Drawings - Other Compnts of Supprt Struct |  | 23d | 2011-05-03 | 2011-06-03 | 14362026 | 306d | 0d |  | MECH DES [400 h]; MECH ENG [200 h] | 32,262 | FENKER H | 1 | 1 | HOWARD F | 10-069 | 11-026 | 11-046 | 12-012 |  | 13-006F |  |  |  |  |  |  |  |  |  |  |  | 09-012 |  | 08-052 | 11-025 | 12-036F | APP |  | 09-022 |  |  |  |  |  |  |
| 14362037 |  | Procurement Prep - Mag Mounts of Supprt Struct |  | 19d | 2011-05-04 | 2011-05-31 | 14362042, 14362036 | 374d | 146d |  | MECH ENG [80 h] | 5,436 | FENKER H | 1 | 1 | HOWARD F | 10-069 | 11-026 | 11-046 | 12-012 |  | 13-006F |  |  |  |  |  |  |  |  |  |  |  |  |  | 08-052 | 11-025 | 12-036F | APP |  | 09-022 |  |  |  |  |  |  |
| 14362031 |  | Produce Drawings - Wheel Section of Supprt Struct |  | 24d | 2011-06-06 | 2011-07-08 | 14362051 | 306d | 0d |  | MECH ENG [200 h]; MECH DES [400 h] | 32,262 | FENKER H | 1 | 1 | HOWARD F | 10-069 | 11-026 | 11-046 | 12-012 |  | 13-006F |  |  |  |  |  |  |  |  |  |  |  |  |  | 08-052 | 11-025 | 12-036F |  |  | 09-022 |  |  |  |  |  |  |
| 14362052 |  | Procurement Prep - Other Compnts of Supprt Struct |  | 20d | 2011-06-06 | 2011-07-01 | 14362027, 14362051 | 314d | 4d |  | MECH ENG [80 h] | 5,436 | FENKER H | 1 | 1 | HOWARD F | 10-069 | 11-026 | 11-046 | 12-012 |  | 13-006F |  |  |  |  |  |  |  |  |  |  |  | 09-012 |  | 08-052 | 11-025 | 12-036F | APP |  | 09-022 |  |  |  |  |  |  |
| 14362021 |  | Produce Drawings - Mag Section of Supprt Struct |  | 23d | 2011-07-11 | 2011-08-10 | 14362031 | 306d | 0d |  | MECH DES [360 h]; MECH ENG [200 h] | 30,394.8 | FENKER H | 1 | 1 | HOWARD F | 10-069 | 11-026 | 11-046 | 12-012 |  | 13-006F |  |  |  |  |  |  |  |  |  |  |  |  |  | 08-052 | 11-025 | 12-036F | APP |  | 09-022 |  |  |  |  |  |  |
| 14362032 |  | Procurement Prep - Wheel Section of Supprt Struct |  | 19d | 2011-07-11 | 2011-08-04 | 14362052, 14362031 | 310d | 4d |  | MECH ENG [80 h] | 5,436 | FENKER H | 1 | 1 | HOWARD F | 10-069 | 11-026 | 11-046 | 12-012 |  | 13-006F |  |  |  |  |  |  |  |  |  |  |  |  |  | 08-052 | 11-025 | 12-036F |  |  | 09-022 |  |  |  |  |  |  |
| 14362022 |  | Procurement Prep - Mag Section of Supprt Struct |  | 18d | 2011-08-11 | 2011-09-06 | 14362032, 14362021 | 306d | 63d |  | MECH ENG [80 h] | 5,436 | FENKER H | 1 | 1 | HOWARD F | 10-069 | 11-026 | 11-046 | 12-012 |  | 13-006F |  |  |  |  |  |  |  |  |  |  |  |  |  | 08-052 | 11-025 | 12-036F | APP |  | 09-022 |  |  |  |  |  |  |
| 14362011 |  | SS/SH Engineering Support FY12 |  | 247d | 2011-10-03 | 2012-09-28 | 9-120M, 14362010M, 14362007 | 296d | 276d |  | PROCUREMENT<$50K 60; PROCUREMENT>$50K 69 | 127,778.11 | FENKER H | 1 | 1 | HOWARD F | 10-069 | 11-026 | 11-046 | 12-012 |  |  |  |  |  |  |  |  |  |  |  |  | 08-016 | 09-012 |  | 08-052 | 11-025 | 12-036F | APP | 4362B | 09-022 |  |  |  |  |  |  |
| 14362050 |  | PreFab Double Bogies of Supprt Struct |  | 150d | 2011-10-03 | 2012-05-11 | 14362047, 9-120M | 238d | 218d |  | MECH DES [80 h]; PROCUREMENT>$50K 69; MECH ENG [160 h]; PROCUREMENT<$50K 60 | 327,576.72 | FENKER H | 1 | 1 | HOWARD F | 10-069 | 11-026 | 11-046 | 12-012 |  | 13-006F |  |  |  |  |  |  |  |  |  |  | 08-016 | 09-012 |  | 08-052 | 11-025 | 12-036F | APP | 4362C | 09-022 |  |  |  |  |  |  |
| 14362050a |  | PreFab Wheels of Supprt Struct |  | 150d | 2011-10-03 | 2012-05-11 | 14362047a, 14362010M, 9-120M | 238d | 218d |  | MECH ENG [80 h]; MECH DES [80 h]; PROCUREMENT>$50K 69 | 172,959.28 | FENKER H | 1 | 1 | HOWARD F | 10-069 | 11-026 | 11-046 | 12-012 |  | 13-006F |  |  |  |  |  |  |  |  |  |  | 08-016 | 09-012 |  | 08-052 | 11-025 | 12-036F | APP | 4362C | 09-022 |  |  |  |  |  |  |
| 14362075a |  | Fab Main Bearing of Supprt Struct Labor FY12 |  | 2d | 2011-10-03 | 2011-10-04 | 14362075 | 381d | 361d |  | MECH ENG [0.64 h]; MECH DES [0.64 h] | 75.71 | FENKER H | 1 | 1 | HOWARD F | 10-069 | 11-026 | 11-046 | 12-012 |  | 13-006F |  |  |  |  |  |  |  |  |  |  | 08-016 | 09-012 |  | 08-052 | 11-025 | 12-036F | APP |  | 09-022 | 12-001 |  |  |  |  |  |
| 14362812LOE |  | Overlook Various Subcontracts of Supprt Struct |  | 247d | 2011-10-03 | 2012-09-28 | 14362811LOE | 1238d | 1301d |  | SCIENTIST [200 h] | 14,122 | FENKER H | 1 | 1 | HOWARD F | 10-069 | 11-026 | 11-046 |  |  |  |  |  |  |  |  |  |  |  |  |  |  |  |  | 08-052 |  |  |  |  | 09-022 |  |  |  |  |  |  |
| 14362015 |  | PreFab Rails & Base of Supprt Struct |  | 100d | 2011-12-07 | 2012-05-04 | 9-120M FS+45d, 14362010M FS-130d, 14362013 | 157d | 137d |  | PROCUREMENT>$50K 69; MECH ENG [80 h]; PROCUREMENT<$50K 60; MECH DES [40 h] | 90,088.4 | FENKER H | 1 | 1 | HOWARD F | 10-069 | 11-026 | 11-046 | 12-012 | 12-054F | 13-006F |  |  |  |  |  |  |  |  |  |  |  |  |  | 08-052 | 11-025 | 12-036F | APP |  | 09-022 |  |  |  |  |  |  |
| 14362020 |  | PreFab Pivot Sections of Supprt Struct |  | 130d | 2011-12-07 | 2012-06-19 | 14362010M, 9-120M FS+45d, 14362017 | 213d | 193d |  | TRAVEL; MECH ENG [80 h]; PROCUREMENT<$50K 60; PROCUREMENT>$50K 69 | 73,560.82 | FENKER H | 1 | 1 | HOWARD F | 10-069 | 11-026 | 11-046 | 12-012 |  | 13-006F |  |  |  |  |  |  |  |  |  |  |  |  |  | 08-052 | 11-025 | 12-036F | APP | 4362A | 09-022 |  |  |  |  |  |  |
| 14362025 |  | PreFab Mag Section #20 of Supprt Struct |  | 100d | 2011-12-07 | 2012-05-04 | 14362010M, 14362022, 9-120M FS+45d | 243d | 223d |  | TRAVEL; MECH DES [320 h]; PROCUREMENT>$50K 69; MECH ENG [240 h]; PROCUREMENT<$50K 60 | 195,741.14 | FENKER H | 1 | 1 | HOWARD F | 10-069 | 11-026 | 11-046 | 12-012 |  | 13-006F |  |  |  |  |  |  |  |  |  |  |  |  |  | 08-052 | 11-025 | 12-036F | APP |  | 09-022 |  |  |  |  |  |  |
| 14362035a |  | PreFab #100 section of Support STructure and Inner Race |  | 120d | 2012-01-04 | 2012-06-25 | 9-120M FS+59d | 209d | 189d |  | PROCUREMENT<$50K 60; PROCUREMENT>$50K 69 | 63,000 | FENKER H | 1 | 1 | HOWARD F | 10-069 | 11-026 | 11-046 | 12-012 |  | 13-006F |  |  |  |  |  |  |  |  |  |  |  |  |  | 08-052 | 11-025 | 12-036F |  |  | 09-022 |  |  |  |  |  |  |
| 14362030 |  | PreFab Detector Section #30 of Supprt Struct |  | 100d | 2012-01-05 | 2012-05-25 | 9-120M FS+60d, 14362037, 14362027 | 228d | 208d |  | MECH DES [40 h]; MECH ENG [80 h]; PROCUREMENT>$50K 69 | 172,696.12 | FENKER H | 1 | 1 | HOWARD F | 10-069 | 11-026 | 11-046 | 12-012 |  | 13-006F |  |  |  |  |  |  |  |  |  |  | 08-016 | 09-012 |  | 08-052 | 11-025 | 12-036F | APP |  | 09-022 |  |  |  |  |  |  |
| 14362035 |  | PreFab Wheel Section of Supprt Struct |  | 100d | 2012-01-05 | 2012-05-25 | 14362010M, 9-120M FS+60d, 14362032 | 228d | 208d |  | TRAVEL; MECH DES [40 h]; PROCUREMENT>$50K 69; PROCUREMENT<$50K 60; MECH ENG [80 h] | 166,285.53 | FENKER H | 1 | 1 | HOWARD F | 10-069 | 11-026 | 11-046 | 12-012 |  | 13-006F |  |  |  |  |  |  |  |  |  |  |  |  |  | 08-052 | 11-025 | 12-036F |  |  | 09-022 |  |  |  |  |  |  |
| 14362065 |  | Electrical System Final Drawings |  | 120d | 2012-01-05 | 2012-06-26 | 9-120M FS+60d | 315d |  |  | ELEC ENG [160 h]; MECH DES [320 h] | 26,704 | FENKER H | 1 | 1 | HOWARD F | 10-069 | 11-026 | 11-046 | 12-012 |  |  |  |  |  |  |  |  |  |  |  |  |  |  |  | 08-052 | 11-025 | 12-036F |  |  | 09-022 |  |  |  |  |  |  |
| 14362070 |  | Fire Safety and HVAC Final Drawings |  | 120d | 2012-01-05 | 2012-06-26 | 9-120M FS+60d | 315d |  |  | MECH DES [160 h]; PLANT ENG [80 h] | 13,326.4 | FENKER H | 1 | 1 | HOWARD F | 10-069 | 11-026 | 11-046 | 12-012 |  |  |  |  |  |  |  |  |  |  |  |  |  |  |  | 08-052 | 11-025 | 12-036F |  |  | 09-022 |  |  |  |  |  |  |
| 14362055 |  | PreFab Other Compnts of Supprt Struct |  | 100d | 2012-01-12 | 2012-06-05 | 14362052, 9-120M FS+65d, 14362010M | 223d | 203d |  | MECH ENG [80 h]; PROCUREMENT<$50K 60; MECH DES [80 h] | 71,377.2 | FENKER H | 1 | 1 | HOWARD F | 10-069 | 11-026 | 11-046 | 12-012 |  | 13-006F |  |  |  |  |  |  |  |  |  |  |  | 09-012 |  | 08-052 | 11-025 | 12-036F | APP |  | 09-022 |  |  |  |  |  |  |
| 14362060 |  | Proc Drive Motors & Reducers of Supprt Struct |  | 60d | 2012-01-12 | 2012-04-06 | 9-120M FS+65d, 14362010M | 293d | 273d |  | MECH ENG [160 h] | 11,219.2 | FENKER H | 1 | 1 | HOWARD F | 10-069 | 11-026 | 11-046 | 12-012 |  |  |  |  |  |  |  |  |  |  |  |  |  |  |  | 08-052 | 11-025 | 12-036F |  |  | 09-022 |  |  |  |  |  |  |
| 14362040 |  | PreFab Mag Mounts of Supprt Struct |  | 100d | 2012-02-03 | 2012-06-26 | 9-120M FS+80d, 14362037 | 208d | 188d |  | MECH ENG [40 h] | 2,804.8 | FENKER H | 1 | 1 | HOWARD F | 10-069 | 11-026 | 11-046 | 12-012 |  | 13-006F |  |  |  |  |  |  |  |  |  |  |  |  |  | 08-052 | 11-025 | 12-036F |  |  | 09-022 |  |  |  |  |  |  |
| 14362045 |  | PreFab Access Platforms of Supprt Struct |  | 100d | 2012-04-02 | 2012-08-21 | 14362042, 9-120M FS+120d | 168d | 148d |  | PROCUREMENT<$50K 60; MECH DES [40 h]; MECH ENG [40 h] | 87,283.6 | FENKER H | 1 | 1 | HOWARD F | 10-069 | 11-026 | 11-046 | 12-012 |  | 13-006F |  |  |  |  |  |  |  |  |  |  | 08-016 | 09-012 |  | 08-052 | 11-025 | 12-036F | APP |  | 09-022 |  |  |  |  |  |  |
| 14362950 |  | Re-Baseline Actuals Adjustment |  | 1d | 2013-08-30 | 2013-08-30 | 9-130M FS+227d | 20d |  |  | PROCUREMENT>$50K 69 NO ESCALATION | -157,840.37 | FENKER H | 1 | 1 | HOWARD F |  |  |  |  |  |  | 13-014 | ADJ |  |  |  |  |  |  |  |  |  |  |  |  |  |  |  |  |  |  |  |  |  |  |  |
| 24362000 |  | Engineering Consulting |  | 20d | 2013-09-03 | 2013-09-30 | 9-130M FS+228d | 551d |  | 8/5 M-F w/JLAB Holidays ReBaseline | PROCUREMENT<$50K 60 | 1,519.7 | FENKER H | 1 | 1 | HOWARD F | 10-069 | 11-026 | 11-046 | 12-012 |  | 13-006F |  |  | 24363030aa | U |  | 13-015 | PR |  | EJ |  |  |  |  | 08-052 | 11-025 |  | APP | 4362B | 09-022 |  | PR in system | y | 10-025 | 12-055 | OB |

| ID | WBS | Activity | Type | Duration | Start | Finish | Predecessors | Total float | Free float | Calendar | Resources | Cost | RESP - Responsibility | STRT%COMP for CM EVM | FNSH%COMP for CM EVM | Milestone Level | CAM RESPONSIBLE | CR 08-052 | CR 10-069 | CR 11-025 | CR 11-026 | CR 11-046 | CR 12-012 | CR 12-036 | CR 13-006 | Advance Purchase Plan > 500K | 12 GEV MAJOR PROCUREMENT CATAGORY | CR 09-012 | CR 09-022 | CR 10-025 | CR 12-001 | CR 12-055 | CR 08-016 | CR 12-054 | CR 13-014 | ReBaseline Actuals Adjustment | BOE NOTES | Original Activity ID Rebaseline | Over Under Fixed | EVMS Reporting Codes | BOE Procurement | CR 13-015 | Post Rebaseline | Obligated Prior to Rebaseline | BOE Labor | CR 14-001 | BOE Expenses | CR 12-053 | CR 12-022 | Howard's Code | Activities with Steps |
| --- | --- | --- | --- | --- | --- | --- | --- | --- | --- | --- | --- | --- | --- | --- | --- | --- | --- | --- | --- | --- | --- | --- | --- | --- | --- | --- | --- | --- | --- | --- | --- | --- | --- | --- | --- | --- | --- | --- | --- | --- | --- | --- | --- | --- | --- | --- | --- | --- | --- | --- | --- |
|  | 3 | **1.4.3.6.3 SHIELD HOUSE** |  |  | 2009-11-02 | 2014-01-30 |  |  |  |  |  |  |  |  |  |  |  |  |  |  |  |  |  |  |  |  |  |  |  |  |  |  |  |  |  |  |  |  |  |  |  |  |  |  |  |  |  |  |  |  |  |
| 14363005M |  | Award Contract for Final Dsgn of Shield House (SHIELD HOUSE) | milestone | 0d | 2009-11-02 | 2009-11-02 | 12236060, 9-100M FS+22d | 440d | 115d |  |  |  | FENKER H | 1 | 1 | 6 | HOWARD F | 08-052 | 10-069 | 11-025 | 11-026 | 11-046 | 12-012 | 12-036F | 13-006F |  |  |  |  |  |  |  |  |  |  |  |  |  |  |  |  |  |  |  |  |  |  |  |  |  |  |
| 14363010 |  | Finalize Dsgn of Shield House (SHIELD HOUSE) |  | 111d | 2010-04-26 | 2010-09-30 | 14363005M, 14362005 FS-111d | 325d | 19d |  | MECH ENG [341.54 h]; MECH DES [341.54 h]; PROCUREMENT<$50K 60; TRAVEL | 56,176.89 | FENKER H | 1 | 1 |  | HOWARD F | 08-052 | 10-069 | 11-025 | 11-026 | 11-046 | 12-012 | 12-036F | 13-006F | APP | 4362B | 09-012 | 09-022 | 10-025 |  |  |  |  |  |  |  |  |  |  |  |  |  |  |  |  |  |  |  |  |  |
| 14363021 |  | Produce Drawings - Steel (SHIELD HOUSE) FY11 |  | 36d | 2011-08-11 | 2011-09-30 | 14362021 | 344d | 0d |  | MECH ENG [301.94 h]; MECH DES [603.87 h] | 48,705.47 | FENKER H | 1 | 1 |  | HOWARD F | 08-052 | 10-069 | 11-025 | 11-026 | 11-046 | 12-012 | 12-036F |  | APP |  | 09-012 | 09-022 |  | 12-001 |  |  |  |  |  |  |  |  |  |  |  |  |  |  |  |  |  |  |  |  |
| 14363021a |  | Produce Drawings - Steel (SHIELD HOUSE) FY12 |  | 26d | 2011-10-03 | 2011-11-07 | 14363021 | 344d | 0d |  | MECH ENG [218.06 h]; MECH DES [436.13 h] | 36,298.75 | FENKER H | 1 | 1 |  | HOWARD F | 08-052 | 10-069 | 11-025 | 11-026 | 11-046 | 12-012 | 12-036F |  | APP |  | 09-012 | 09-022 |  | 12-001 |  |  |  |  |  |  |  |  |  |  |  |  |  |  |  |  |  |  |  |  |
| 14363022 |  | Procurement Prep - Steel (SHIELD HOUSE) |  | 20d | 2011-11-08 | 2011-12-07 | 14363021a | 349d | 0d |  | MECH ENG [80 h] | 5,609.6 | FENKER H | 1 | 1 |  | HOWARD F | 08-052 | 10-069 | 11-025 | 11-026 | 11-046 | 12-012 | 12-036F |  | APP |  | 09-012 | 09-022 |  |  |  |  |  |  |  |  |  |  |  |  |  |  |  |  |  |  |  |  |  |  |
| 14363025 |  | Fab Steel Supprt (SHIELD HOUSE) |  | 100d | 2011-12-08 | 2012-05-07 | 9-120M, 14362010M, 14363022 | 349d |  |  | MECH DES [160 h]; MECH ENG [160 h]; MECH TECH [160 h] | 26,036.8 | FENKER H | 1 | 1 |  | HOWARD F | 08-052 | 10-069 | 11-025 | 11-026 | 11-046 | 12-012 | 12-036F |  | APP |  | 09-012 | 09-022 |  |  |  |  |  |  |  |  |  |  |  |  |  |  |  |  |  |  |  |  |  |  |
| 14363021b |  | Produce Drawings FY13 |  | 147d | 2013-01-02 | 2013-07-31 | 9-130M FS+59d | 42d |  |  | MECH DES [640 h] | 31,814.4 | FENKER H | 1 | 1 |  | HOWARD F |  |  |  |  |  |  |  | 13-006 | APP |  |  |  |  |  |  |  |  |  |  |  |  |  |  |  |  |  |  |  |  |  |  |  |  |  |
| 14363030 |  | Proc Boron and Lead Shielding (SHIELD HOUSE) Part A |  | 60d | 2013-01-03 | 2013-03-29 | 14363021a, 9-130M FS+60d | 63d | 0d |  | PROCUREMENT>$50K 69; PROCUREMENT<$50K 60 | 531,428.5 | FENKER H | 1 | 1 |  | HOWARD F | 08-052 | 10-069 | 11-025 | 11-026 | 11-046 | 12-012 |  |  | APP | 4362B |  | 09-022 | 10-025 |  | 12-055 |  |  |  |  |  |  |  |  |  |  |  |  |  |  |  |  |  |  |  |
| 14363030a |  | Proc Boron and Lead Shielding (SHIELD HOUSE) Part B |  | 60d | 2013-01-03 | 2013-03-29 | 9-130M FS+60d, 14363021a | 63d | 0d |  | PROCUREMENT>$50K 69 | 61,914 | FENKER H | 1 | 1 |  | HOWARD F | 08-052 | 10-069 | 11-025 | 11-026 | 11-046 | 12-012 |  |  | APP | 4362B |  | 09-022 | 10-025 |  | 12-055 |  |  |  |  |  |  |  |  |  |  |  |  |  |  |  |  |  |  |  |
| 14363060 |  | Fab Various Small Components (SHIELD HOUSE) |  | 65d | 2013-04-01 | 2013-07-01 | 14363030, 14363030a | 63d |  |  | PROCUREMENT<$50K 60; MECH ENG [80 h]; MSHOP | 45,437.5 | FENKER H | 1 | 1 |  | HOWARD F | 08-052 | 10-069 | 11-025 | 11-026 | 11-046 |  |  |  | APP |  | 09-012 | 09-022 |  |  |  | 08-016 |  |  |  |  |  |  |  |  |  |  |  |  |  |  |  |  |  |  |
| 14363035 |  | Fab Doors and associated hardware for Shield House (SHIELD HOUSE) (Future Activity Complete prior to Rebaseline) |  | 1d | 2013-08-30 | 2013-08-30 | 9-130M FS+227d | 20d |  |  | PROCUREMENT<$50K 60; PROCUREMENT>$50K 69; MECH DES; PROCUREMENT<$50K 60 NO ESCALATION FY14; PROCUREMENT>$50K 69 NO ESCALATION FY14 |  | FENKER H | 1 | 1 |  | HOWARD F | 08-052 | 10-069 | 11-025 | 11-026 | 11-046 |  | 12-036 | 13-006 | APP |  |  | 09-022 |  |  |  |  | 12-054 | 13-014 |  |  |  |  |  |  |  |  |  |  |  |  |  |  |  |  |
| 14363065 |  | Re-Baseline Actuals Adjustment |  | 1d | 2013-08-30 | 2013-08-30 | 9-130M FS+227d | 20d |  |  | PROCUREMENT>$50K 69 NO ESCALATION | -28,609.09 | FENKER H | 1 | 1 |  | HOWARD F |  |  |  |  |  |  |  |  |  |  |  |  |  |  |  |  |  | 13-014 | ADJ |  |  |  |  |  |  |  |  |  |  |  |  |  |  |  |
| 24363030aa |  | Assemble Cast Panels and Lead Sheets (SHIELD HOUSE) |  | 77d | 2013-09-03 | 2013-12-20 | 9-130M FS+228d | 186d | 0d | 8/5 M-F w/JLAB Holidays ReBaseline | PROCUREMENT<$50K 60 NO ESCALATION FY14 | 7,775 | FENKER H | 1 | 1 |  | HOWARD F | 08-052 | 10-069 | 11-025 | 11-026 | 11-046 | 12-012 |  | 13-006F | APP | 4362B |  | 09-022 | 10-025 |  | 12-055 |  |  |  |  | PR in system | 24363030aa | y | U | EJ | 13-015 | PR | OB |  |  |  |  |  |  |  |
| 24363035 |  | Fab Doors and associated hardware for Shield House (SHIELD HOUSE) Part A |  | 77d | 2013-09-03 | 2013-12-20 | 9-130M FS+228d | 209d | 23d | 8/5 M-F w/JLAB Holidays ReBaseline | PROCUREMENT<$50K 60 NO ESCALATION FY14 | 15,589.85 | FENKER H | 1 | 1 |  | HOWARD F | 08-052 | 10-069 | 11-025 | 11-026 | 11-046 |  | 12-036 | 13-006 | APP |  |  | 09-022 |  |  |  |  | 12-054 |  |  |  | 24363035 | y | D | EJ | 13-015 | PR | OB | EJ |  |  |  |  |  |  |
| 24363036 |  | Fab Doors and associated hardware for Shield House (SHIELD HOUSE) Part B |  | 77d | 2013-09-03 | 2013-12-20 | 9-130M FS+228d | 209d | 23d | 8/5 M-F w/JLAB Holidays ReBaseline | PROCUREMENT<$50K 60 NO ESCALATION FY14 | 1,987 | FENKER H | 1 | 1 |  | HOWARD F | 08-052 | 10-069 | 11-025 | 11-026 | 11-046 |  | 12-036 | 13-006 | APP |  |  | 09-022 |  |  |  |  | 12-054 |  |  |  | 24363035 | y | D | EJ | 13-015 | PR | OB | EJ |  |  |  |  |  |  |
| 24363037 |  | Fab Doors and associated hardware for Shield House (SHIELD HOUSE) Part C Procurement |  | 97d | 2013-09-03 | 2014-01-30 | 9-130M FS+228d | 189d | 3d | 8/5 M-F w/JLAB Holidays ReBaseline | MECH DES; PROCUREMENT<$50K 60 NO ESCALATION FY14 | 8,111.15 | FENKER H | 1 | 1 |  | HOWARD F | 08-052 | 10-069 | 11-025 | 11-026 | 11-046 |  | 12-036 | 13-006 | APP |  |  | 09-022 |  |  |  |  | 12-054 |  |  |  | 24363035 |  | D | EJ | 13-015 | PR |  | EJ |  |  |  |  |  |  |
| 24363037a |  | Fab Doors and associated hardware for Shield House (SHIELD HOUSE) Part C Labor FY13 |  | 20d | 2013-09-03 | 2013-09-30 | 9-130M FS+228d | 189d | 0d | 8/5 M-F w/JLAB Holidays ReBaseline | MECH DES [15.67 h] | 778.96 | FENKER H | 1 | 1 |  | HOWARD F | 08-052 | 10-069 | 11-025 | 11-026 | 11-046 |  | 12-036 | 13-006 | APP |  |  | 09-022 |  |  |  |  | 12-054 |  |  |  | 24363035 |  | D | EJ | 13-015 | PR |  | EJ |  |  |  |  |  |  |
| 24363041 |  | Plastic Pellets |  | 20d | 2013-09-03 | 2013-09-30 | 9-130M FS+228d | 551d |  | 8/5 M-F w/JLAB Holidays ReBaseline | PROCUREMENT<$50K 60 | 1,948.95 | FENKER H | 1 | 1 |  | HOWARD F | 08-052 | 10-069 | 11-025 | 11-026 | 11-046 |  | 12-036 | 13-006 | APP |  |  | 09-022 |  |  |  |  | 12-054 |  |  |  | 24363035 | y | D | EJ | 13-015 | PR | OB | EJ |  |  |  |  |  |  |
| 24363046 |  | Rental Containers for Plastic Pellets |  | 20d | 2013-09-03 | 2013-09-30 | 9-130M FS+228d | 551d |  | 8/5 M-F w/JLAB Holidays ReBaseline | PROCUREMENT<$50K 60 | 335.62 | FENKER H | 1 | 1 |  | HOWARD F | 08-052 | 10-069 | 11-025 | 11-026 | 11-046 |  | 12-036 | 13-006 | APP |  |  | 09-022 |  |  |  |  | 12-054 |  |  |  | 24363035 | y | D | EJ | 13-015 | PR | OB | EJ |  |  |  |  |  |  |
| 24363037b |  | Fab Doors and associated hardware for Shield House (SHIELD HOUSE) Part C Labor FY14 |  | 77d | 2013-10-01 | 2014-01-30 | 9-130M FS+228d, 24363037a | 189d | 3d | 8/5 M-F w/JLAB Holidays ReBaseline | MECH DES [60.33 h] | 3,094.93 | FENKER H | 1 | 1 |  | HOWARD F | 08-052 | 10-069 | 11-025 | 11-026 | 11-046 |  | 12-036 | 13-006 | APP |  |  | 09-022 |  |  |  |  | 12-054 |  |  |  | 24363035 |  | D | EJ | 13-015 | PR |  | EJ | 14-001 |  |  |  |  |  |
| 24363060 |  | Fab Various Small Components (SHIELD HOUSE) |  | 65d | 2013-10-01 | 2014-01-13 | 24363030aa FS-57d | 404d | 360d | 8/5 M-F w/JLAB Holidays ReBaseline | PROCUREMENT<$50K 60; MECH ENG [80 h]; MSHOP | 46,887.09 | FENKER H | 1 | 1 |  | HOWARD F | 08-052 | 10-069 | 11-025 | 11-026 | 11-046 |  |  | 13-006F | APP |  | 09-012 | 09-022 |  |  |  | 08-016 |  |  |  |  | 24363060 |  | D | EJ | 13-015 | PR |  | EJ | 14-001 | EJ |  |  |  |  |
|  | 4 | **1.4.3.6.4 CRYOGENIC SYSTEM** |  |  | 2010-10-01 | 2014-03-20 |  |  |  |  |  |  |  |  |  |  |  |  |  |  |  |  |  |  |  |  |  |  |  |  |  |  |  |  |  |  |  |  |  |  |  |  |  |  |  |  |  |  |  |  |  |
| 14364005 |  | Update Overall Cryo Flow Sheet (CRYO SYS) |  | 40d | 2010-10-01 | 2010-11-29 | 12236015b, 9-110M | 393d | 208d |  | MECH ENG [80 h]; MECH DES [160 h] | 12,904.8 | FENKER H | 1 | 1 |  | HOWARD F |  | 10-069 |  | 11-026 | 11-046 | 12-012 | 12-036F |  |  |  |  |  |  |  |  |  |  |  |  |  |  |  |  |  |  |  |  |  |  |  |  |  |  |  |
| 14364010 |  | Proc Equipmnt for Mod of G0 Transfer Line (CRYO SYS) |  | 40d | 2011-10-03 | 2011-11-29 | 9-120M, 14364005 | 185d | 0d |  | PROCUREMENT>$50K 69 | 36,223.38 | FENKER H | 1 | 1 |  | HOWARD F |  | 10-069 |  | 11-026 | 11-046 | 12-012 | 12-036F |  |  |  |  |  |  |  |  |  |  |  |  |  |  |  |  |  |  |  |  |  |  |  |  |  |  |  |
| 14364015 |  | Detail Mods of G0 Transfer Line |  | 18d | 2011-11-30 | 2011-12-30 | 14364010 | 380d | 360d |  | MECH TECH [48 h]; MECH DES [48 h]; MECH ENG [24 h] | 6,128.16 | FENKER H | 1 | 1 |  | HOWARD F |  | 10-069 |  | 11-026 | 11-046 | 12-012 | 12-036F | 13-006F |  |  |  |  |  |  |  |  |  |  |  |  |  |  |  |  |  |  |  |  |  |  |  |  |  |  |
| 14364025 |  | Fab SHMS Distrbtn Transfer Line (CRYO SYS) |  | 60d | 2011-11-30 | 2012-03-02 | 14364010 | 185d | 0d |  | MECH ENG [160 h]; PLABOR; MECH TECH [320 h] | 50,794.03 | FENKER H | 1 | 1 |  | HOWARD F |  | 10-069 | 11-025 | 11-026 | 11-046 | 12-012 | 12-036F |  |  |  |  | 09-022 |  |  |  |  |  |  |  |  |  |  |  |  |  |  |  |  |  |  |  |  |  |  |
| 14364020 |  | Proc SHMS Distrbtn Transfer Line and Relief Stacks (CRYO SYS) FY12 |  | 147d | 2012-03-05 | 2012-09-28 | 14364025 | 185d | 0d |  | TRAVEL | 5,427.24 | FENKER H | 1 | 1 |  | HOWARD F |  | 10-069 | 11-025 | 11-026 | 11-046 | 12-012 | 12-036F |  |  |  |  |  |  |  |  |  |  |  |  |  |  |  |  |  |  |  |  |  |  |  | 12-053 |  |  |  |
| 14364020b |  | Proc SHMS Distrbtn Transfer Line and Relief Stacks (CRYO SYS) Procurement |  | 180d | 2012-03-05 | 2012-11-14 | 14364025 | 185d | 0d |  | PROCUREMENT<$50K 60 NO ESCALATION FY13; PROCUREMENT>$50K 69 NO ESCALATION FY13 | 330,000 | FENKER H | 1 | 1 |  | HOWARD F |  | 10-069 | 11-025 | 11-026 | 11-046 | 12-012 | 12-036F |  |  |  |  |  |  |  |  |  |  |  |  |  |  |  |  |  |  |  |  |  |  |  | 12-053 |  |  |  |
| 14364030 |  | Fab SHMS Gas Manifolds (CRYO SYS) |  | 60d | 2012-03-05 | 2012-05-25 | 14364020a FS-180d, 14364020b FS-180d | 185d | 0d |  | MECH ENG [80 h]; MECH DES [80 h]; PROCUREMENT<$50K 60; TRAVEL; MECH TECH [160 h] | 52,796.97 | FENKER H | 1 | 1 |  | HOWARD F |  | 10-069 |  | 11-026 | 11-046 | 12-012 | 12-036F |  |  |  | 09-012 | 09-022 |  |  |  | 08-016 |  |  |  |  |  |  |  |  |  |  |  |  |  |  |  |  |  |  |
| 14364035 |  | Fab Jlab U-tubes (CRYO SYS) |  | 80d | 2012-05-29 | 2012-09-19 | 9-120M, 14364030 | 255d |  |  | MECH DES [120 h]; MECH ENG [40 h]; PROCUREMENT<$50K 60 | 52,050.91 | FENKER H | 1 | 1 |  | HOWARD F |  | 10-069 |  | 11-026 | 11-046 | 12-012 | 12-036F |  |  |  |  | 09-022 |  |  |  |  |  |  |  |  |  |  |  |  |  |  |  |  |  |  |  |  |  |  |
| 14364040 |  | Fab Jlab L tubes (CRYO SYS) |  | 80d | 2012-05-29 | 2012-09-19 | 14364030 | 255d |  |  | MECH DES [160 h]; MECH ENG [40 h]; PROCUREMENT>$50K 69 | 34,660.93 | FENKER H | 1 | 1 |  | HOWARD F |  | 10-069 |  | 11-026 | 11-046 | 12-012 | 12-036F |  |  |  |  | 09-022 |  |  |  |  |  |  |  |  |  |  |  |  |  |  |  |  |  |  |  |  |  |  |
| 14364060 |  | Fab Stand & Catwalk (CRYO SYS) |  | 150d | 2012-05-29 | 2013-01-07 | 14364030 | 185d |  |  |  |  | FENKER H | 1 | 1 |  | HOWARD F |  | 10-069 |  | 11-026 | 11-046 | 12-012 | 12-036F |  |  |  |  | 09-022 |  |  |  |  |  |  |  |  |  |  |  |  |  |  |  |  |  |  |  |  |  |  |
| 14364020a |  | Proc SHMS Distrbtn Transfer Line and Relief Stacks (CRYO SYS) FY13 |  | 33d | 2012-10-01 | 2012-11-14 | 14364020 | 185d | 0d |  | TRAVEL | 1,257.26 | FENKER H | 1 | 1 |  | HOWARD F |  | 10-069 | 11-025 | 11-026 | 11-046 | 12-012 | 12-036F |  |  |  |  |  |  |  |  |  |  |  |  |  |  |  |  |  |  |  |  |  |  |  | 12-053 |  |  |  |
| 14364043 |  | Produce Drawings for Cryo System Connections & Controls |  | 60d | 2013-01-02 | 2013-03-28 | 9-130M FS+59d | 67d | 0d |  | MECH DES [320 h]; MECH ENG [320 h] | 39,062.4 | FENKER H | 1 | 1 |  | HOWARD F |  |  |  |  |  |  |  | 13-006 |  |  |  |  |  |  |  |  |  |  |  |  |  |  |  |  |  |  |  |  |  |  |  |  |  |  |
| 14364045 |  | Proc Valves & Controllers (CRYO SYS) |  | 40d | 2013-03-29 | 2013-05-23 | 14364030, 14364043, 9-130M FS+80d | 89d |  |  | MECH ENG [40 h]; PROCUREMENT<$50K 60 | 32,799.95 | FENKER H | 1 | 1 |  | HOWARD F |  | 10-069 |  | 11-026 | 11-046 | 12-012 | 12-036F | 13-006 |  |  |  | 09-022 |  |  |  |  |  |  |  |  |  |  |  |  |  |  |  |  |  |  |  | 12-022 |  |  |
| 14364050 |  | Proc Boom Supprt (CRYO SYS) |  | 60d | 2013-03-29 | 2013-06-21 | 14364030, 14364043, 9-130M FS+80d | 67d | 32d |  | PROCUREMENT<$50K 60 | 20,681.56 | FENKER H | 1 | 1 |  | HOWARD F |  | 10-069 |  | 11-026 | 11-046 | 12-012 | 12-036F | 13-006 |  |  |  | 09-022 |  |  |  |  |  |  |  |  |  |  |  |  |  |  |  |  |  |  |  | 12-022 |  |  |
| 14364055 |  | Proc Vac Gauges (CRYO SYS) |  | 40d | 2013-03-29 | 2013-05-23 | 9-130M FS+80d, 14364030, 14364043 | 89d |  |  | PROCUREMENT<$50K 60 | 14,946.73 | FENKER H | 1 | 1 |  | HOWARD F |  | 10-069 |  | 11-026 | 11-046 | 12-012 | 12-036F | 13-006 |  |  |  | 09-022 |  |  |  |  |  |  |  |  |  |  |  |  |  |  |  |  |  |  |  | 12-022 |  |  |
| 14364075 |  | Proc & Fab Various Connections etc (CRYO SYS) |  | 50d | 2013-03-29 | 2013-06-07 | 14364043, 14364030, 9-130M FS+80d | 79d |  |  | SUPPLIES & MATERIALS; MECH ENG [40 h]; PROCUREMENT>$50K 69 | 58,467.75 | FENKER H | 1 | 1 |  | HOWARD F |  | 10-069 |  | 11-026 | 11-046 | 12-012 | 12-036F | 13-006 |  |  | 09-012 | 09-022 |  |  |  | 08-016 |  |  |  |  |  |  |  |  |  |  |  |  |  |  |  | 12-022 |  |  |
| 14364065 |  | Proc Cables,panels & Pwr Supplies (CRYO SYS) |  | 40d | 2013-05-03 | 2013-06-28 | 9-130M FS+144d | 64d |  |  | PROCUREMENT<$50K 60; MECH ENG [80 h]; MECH DES [80 h] | 22,225.25 | FENKER H | 1 | 1 |  | HOWARD F |  | 10-069 |  | 11-026 | 11-046 | 12-012 | 12-036F |  |  |  |  | 09-022 |  |  |  |  | 12-054 |  |  |  |  |  |  |  |  |  |  |  |  |  |  |  |  |  |
| 14364016 |  | Modify G0 Transfer Line |  | 57d | 2013-06-12 | 2013-08-30 | 14368175 FS+20d, 14364015 | 20d |  |  | MECH TECH [1235.89 h]; MECH DES [349.46 h]; MECH ENG [25.57 h] | 75,899.82 | FENKER H | 1 | 1 |  | HOWARD F |  | 10-069 |  | 11-026 | 11-046 | 12-012 | 12-036F | 13-006 |  |  |  |  |  |  |  |  | 12-054 | 13-014 |  |  |  |  |  |  |  |  |  |  |  |  |  |  |  |  |
| 14364080 |  | Re-Baseline Actuals Adjustment |  | 1d | 2013-08-30 | 2013-08-30 | 9-130M FS+227d | 20d |  |  | PROCUREMENT>$50K 69 NO ESCALATION | -63,930.06 | FENKER H | 1 | 1 |  | HOWARD F |  |  |  |  |  |  |  |  |  |  |  |  |  |  |  |  |  | 13-014 | ADJ |  |  |  |  |  |  |  |  |  |  |  |  |  |  |  |
| 24364030 |  | Fab SHMS Gas Manifolds (CRYO SYS) Part A Procurement |  | 38d | 2013-09-03 | 2013-10-24 | 9-130M FS+228d | 282d | 0d | 8/5 M-F w/JLAB Holidays ReBaseline | MECH ENG; MECH DES; TRAVEL; MECH TECH; PROCUREMENT<$50K 60 NO ESCALATION FY14 | 10,195.65 | FENKER H | 1 | 1 |  | HOWARD F |  | 10-069 |  | 11-026 | 11-046 | 12-012 | 12-036F | 13-006F |  |  | 09-012 | 09-022 |  |  |  | 08-016 |  |  |  |  | 24364030 | y | U | EJ | 13-015 | PR | OB | EJ |  | EJ |  |  | 4 |  |
| 24364030a |  | Fab SHMS Gas Manifolds (CRYO SYS) Part A Labor FY13 |  | 20d | 2013-09-03 | 2013-09-30 | 9-130M FS+228d | 282d | 0d | 8/5 M-F w/JLAB Holidays ReBaseline | MECH ENG [42.1 h]; MECH DES [42.1 h] | 5,139.76 | FENKER H | 1 | 1 |  | HOWARD F |  | 10-069 |  | 11-026 | 11-046 | 12-012 | 12-036F | 13-006F |  |  | 09-012 | 09-022 |  |  |  | 08-016 |  |  |  |  | 24364030 |  | U | EJ | 13-015 | PR |  | EJ |  | EJ |  |  | 4 |  |
| 24364043 |  | Produce Drawings for Cryo System Connections & Controls FY13 |  | 20d | 2013-09-03 | 2013-09-30 | 9-130M FS+228d | 287d | 0d | 8/5 M-F w/JLAB Holidays ReBaseline | MECH DES [24.8 h]; MECH ENG [24.8 h] | 3,027.95 | FENKER H | 1 | 1 |  | HOWARD F |  |  |  |  |  |  |  | 13-006 |  |  |  |  |  |  |  |  |  |  |  |  | 24364043 |  | S |  | 13-015 | PR |  | EJ |  |  |  |  |  | ST |
| 24364030b |  | Fab SHMS Gas Manifolds (CRYO SYS) Part A Labor FY14 |  | 18d | 2013-10-01 | 2013-10-24 | 9-130M FS+228d, 24364030a | 282d | 0d | 8/5 M-F w/JLAB Holidays ReBaseline | MECH ENG [37.9 h]; MECH DES [37.9 h] | 4,773.63 | FENKER H | 1 | 1 |  | HOWARD F |  | 10-069 |  | 11-026 | 11-046 | 12-012 | 12-036F | 13-006F |  |  | 09-012 | 09-022 |  |  |  | 08-016 |  |  |  |  | 24364030 |  | U | EJ | 13-015 | PR |  | EJ | 14-001 | EJ |  |  | 4 |  |
| 24364043a |  | Produce Drawings for Cryo System Connections & Controls FY14 |  | 18d | 2013-10-01 | 2013-10-24 | 9-130M FS+228d, 24364043 | 287d | 5d | 8/5 M-F w/JLAB Holidays ReBaseline | MECH DES [28.53 h]; MECH ENG [28.53 h] | 3,593.93 | FENKER H | 1 | 1 |  | HOWARD F |  |  |  |  |  |  |  | 13-006 |  |  |  |  |  |  |  |  |  |  |  |  | 24364043 |  | S |  | 13-015 | PR |  | EJ | 14-001 |  |  |  |  | ST |
| 24364065 |  | Proc Cables,panels & Pwr Supplies (CRYO SYS) |  | 38d | 2013-10-01 | 2013-11-21 | 9-140M | 312d | 74d | 8/5 M-F w/JLAB Holidays ReBaseline | PROCUREMENT<$50K 60; MECH ENG [80 h]; MECH DES [80 h] | 22,934.71 | FENKER H | 1 | 1 |  | HOWARD F |  | 10-069 |  | 11-026 | 11-046 | 12-012 | 12-036F | 13-006F |  |  |  | 09-022 |  |  |  |  | 12-054 |  |  |  | 24364065 |  | D | CP | 13-015 | PR |  | EJ | 14-001 |  |  |  |  |  |
| 24364016 |  | Modify G0 Transfer Line |  | 107d | 2013-10-08 | 2014-03-20 | 24368170 FS+5d | 238d | 0d | 8/5 M-F w/JLAB Holidays ReBaseline | MECH DES [656 h]; MECH ENG [48 h]; MECH TECH [2320 h] | 147,019.36 | FENKER H | 1 | 1 |  | HOWARD F |  | 10-069 |  | 11-026 | 11-046 | 12-012 | 12-036F | 13-006 |  |  |  |  |  |  |  |  | 12-054 |  |  |  | 24364016 |  | U |  | 13-015 | PR |  | EJ | 14-001 |  |  |  | 4 |  |
| 24364075 |  | Proc & Fab Various Connections etc (CRYO SYS) |  | 50d | 2013-10-25 | 2014-01-16 | 24364043a FS-5d, 24364030b, 24364030, 24364043 FS-5d, 24364030a | 282d | 44d | 8/5 M-F w/JLAB Holidays ReBaseline | SUPPLIES & MATERIALS; MECH ENG [40 h]; PROCUREMENT>$50K 69 | 80,961.13 | FENKER H | 1 | 1 |  | HOWARD F |  | 10-069 |  | 11-026 | 11-046 | 12-012 | 12-036F | 13-006F |  |  | 09-012 | 09-022 |  |  |  | 08-016 |  |  |  |  | 24364075 |  | D | EJ | 13-015 | PR |  | EJ | 14-001 | EJ |  | 12-022 |  |  |

Notes:
- 24364043: Steps: Complete design of downstream beam-pipe system; Detail drawings for Pipe Section 1; Detail drawings for Pipe Section 2; Detail drawings for Pipe Section 3; Detail drawings for Beam-pipe Flanges and Vacuum Fittings; Detail drawings for Beam-pipe stands
- 24364043a: Steps: Complete design of downstream beam-pipe system; Detail drawings for Pipe Section 1; Detail drawings for Pipe Section 2; Detail drawings for Pipe Section 3; Detail drawings for Beam-pipe Flanges and Vacuum Fittings; Detail drawings for Beam-pipe stands

| ID | WBS | Activity | Duration | Start | Finish | Predecessors | Total float | Free float | Calendar | Resources | Cost | RESP - Responsibility | STRT%COMP for CM EVM | FNSH%COMP for CM EVM | CAM RESPONSIBLE | CR 10-069 | CR 11-026 | CR 11-046 | CR 12-012 | CR 12-036 | CR 13-006 | CR 09-022 | CR 08-016 | CR 09-012 | CR 12-054 | CR 13-014 | ReBaseline Actuals Adjustment | Original Activity ID Rebaseline | Over Under Fixed | EVMS Reporting Codes | BOE Procurement | BOE Labor | CR 13-015 | Post Rebaseline | Obligated Prior to Rebaseline | BOE Expenses | CR 14-001 | CR 12-022 |
| --- | --- | --- | --- | --- | --- | --- | --- | --- | --- | --- | --- | --- | --- | --- | --- | --- | --- | --- | --- | --- | --- | --- | --- | --- | --- | --- | --- | --- | --- | --- | --- | --- | --- | --- | --- | --- | --- | --- |
|  | 5 | **1.4.3.6.5 VACUUM SYSTEM** |  | 2009-01-05 | 2015-03-31 |  |  |  |  |  |  |  |  |  |  |  |  |  |  |  |  |  |  |  |  |  |  |  |  |  |  |  |  |  |  |  |  |  |
| 14365005 |  | Finalize Drawing for Comp Vac Sys | 60d | 2009-01-05 | 2009-03-31 | 12236025, 12236010b, 12236020 | 88d | 0d |  | MECH ENG [40 h]; MECH DES [160 h] | 9,566.8 | FENKER H | 1 | 1 | HOWARD F | 10-069 | 11-026 | 11-046 | 12-012 | 12-036F | 13-006F |  |  |  |  |  |  |  |  |  |  |  |  |  |  |  |  |  |
| 14365023 |  | Manufacturing Drawings for Vacuum System Parts | 120d | 2013-01-02 | 2013-06-21 | 9-130M FS+59d | 69d |  |  | MECH DES [800 h] | 39,768 | FENKER H | 1 | 1 | HOWARD F |  |  |  |  |  | 13-006 |  |  |  |  |  |  |  |  |  |  |  |  |  |  |  |  |  |
| 14365010 |  | Proc Turbo Pump systems | 40d | 2013-01-03 | 2013-03-01 | 14365005 FS+931d, 2-02M | 88d | 0d |  | MECH TECH [40 h]; PROCUREMENT>$50K 69; MECH ENG [40 h]; PROCUREMENT<$50K 60 | 98,176.07 | FENKER H | 1 | 1 | HOWARD F | 10-069 | 11-026 | 11-046 | 12-012 | 12-036F | 13-006F | 09-022 |  |  |  |  |  |  |  |  |  |  |  |  |  |  |  |  |
| 14365015 |  | Proc Roots Pump Sys | 40d | 2013-01-03 | 2013-03-01 | 2-02M, 14365005 FS+931d | 88d | 0d |  | PROCUREMENT<$50K 60; MECH ENG [20 h] | 45,055.92 | FENKER H | 1 | 1 | HOWARD F | 10-069 | 11-026 | 11-046 | 12-012 | 12-036F | 13-006F | 09-022 |  |  |  |  |  |  |  |  |  |  |  |  |  |  |  |  |
| 14365035 |  | Proc Windows & Flanges | 130d | 2013-01-03 | 2013-07-09 | 14365005, 9-130M FS+60d | 58d |  |  | PROCUREMENT<$50K 60 | 37,378.91 | FENKER H | 1 | 1 | HOWARD F | 10-069 | 11-026 | 11-046 | 12-012 |  | 13-006F | 09-022 | 08-016 | 09-012 | 12-054 |  |  |  |  |  |  |  |  |  |  |  |  |  |
| 14365040 |  | Proc Shutter Exit Window | 130d | 2013-01-03 | 2013-07-09 | 9-130M FS+60d, 14365005 | 58d |  |  | PROCUREMENT<$50K 60 | 24,919.28 | FENKER H | 1 | 1 | HOWARD F | 10-069 | 11-026 | 11-046 | 12-012 |  | 13-006F | 09-022 | 08-016 | 09-012 | 12-054 |  |  |  |  |  |  |  |  |  |  |  |  |  |
| 14365020 |  | Proc Valves & Plumbing | 60d | 2013-03-04 | 2013-05-24 | 14365010, 14365015 | 88d |  |  | MECH ENG [40 h]; PROCUREMENT>$50K 69 | 40,273.31 | FENKER H | 1 | 1 | HOWARD F | 10-069 | 11-026 | 11-046 | 12-012 | 12-036F | 13-006 | 09-022 |  |  |  |  |  |  |  |  |  |  |  |  |  |  |  |  |
| 14365025 |  | Proc Gauges for Vac Sys | 60d | 2013-03-04 | 2013-05-24 | 2-02M, 14365015, 14365010 | 88d |  |  | PROCUREMENT<$50K 60 | 24,919.28 | FENKER H | 1 | 1 | HOWARD F | 10-069 | 11-026 | 11-046 | 12-012 | 12-036F | 13-006 | 09-022 |  |  |  |  |  |  |  |  |  |  |  |  |  |  |  |  |
| 14365055 |  | Re-Baseline Actuals Adjustment | 1d | 2013-08-30 | 2013-08-30 | 9-130M FS+227d | 20d |  |  | PROCUREMENT>$50K 69 NO ESCALATION | -108,783.13 | FENKER H | 1 | 1 | HOWARD F |  |  |  |  |  |  |  |  |  |  | 13-014 | ADJ |  |  |  |  |  |  |  |  |  |  |  |
| 24365020 |  | Proc Valves & Plumbing and Reliefs Part A Procurement | 62d | 2013-09-03 | 2013-11-27 | 9-130M FS+228d | 358d |  | 8/5 M-F w/JLAB Holidays ReBaseline | PROCUREMENT<$50K 60 NO ESCALATION FY14; MECH ENG | 20,707 | FENKER H | 1 | 1 | HOWARD F | 10-069 | 11-026 | 11-046 | 12-012 | 12-036F | 13-006 | 09-022 |  |  |  |  |  | 24365020 | y | D | EJ | EJ | 13-015 | PR | OB |  |  |  |
| 24365020a |  | Proc Valves & Plumbing and Reliefs Part A Labor FY13 | 20d | 2013-09-03 | 2013-09-30 | 9-130M FS+228d | 358d | 0d | 8/5 M-F w/JLAB Holidays ReBaseline | MECH ENG [6.45 h] | 466.72 | FENKER H | 1 | 1 | HOWARD F | 10-069 | 11-026 | 11-046 | 12-012 | 12-036F | 13-006 | 09-022 |  |  |  |  |  | 24365020 |  | D | EJ | EJ | 13-015 | PR |  |  |  |  |
| 24365023 |  | Manufacturing Drawings for Vacuum System Parts FY13 | 20d | 2013-09-03 | 2013-09-30 | 9-130M FS+228d | 150d | 0d | 8/5 M-F w/JLAB Holidays ReBaseline | MECH DES [40.82 h] | 2,029.16 | FENKER H | 1 | 1 | HOWARD F |  |  |  |  |  | 13-006 |  |  |  |  |  |  | 24365023 |  | H |  | EJ | 13-015 | PR |  |  |  |  |
| 24365025 |  | Proc Valves & Plumbing and Reliefs Part B | 267d | 2013-09-03 | 2014-09-30 | 9-130M FS+228d | 153d |  | 8/5 M-F w/JLAB Holidays ReBaseline | PROCUREMENT<$50K 60 NO ESCALATION FY14 | 88,724.36 | FENKER H | 1 | 1 | HOWARD F | 10-069 | 11-026 | 11-046 | 12-012 | 12-036F | 13-006 | 09-022 |  |  |  |  |  | 24365025 |  | D | OB |  | 13-015 | PR |  |  |  |  |
| 24365030 |  | Proc Spool & Bellows for All Magnets Part A | 203d | 2013-09-03 | 2014-06-30 | 24365023 FS-100d, 9-130M FS+228d, 24365023a FS-100d | 198d | 0d | 8/5 M-F w/JLAB Holidays ReBaseline | PROCUREMENT<$50K 60 NO ESCALATION FY14 | 14,446.86 | FENKER H | 1 | 1 | HOWARD F | 10-069 | 11-026 | 11-046 | 12-012 |  | 13-006 | 09-022 |  |  | 12-054 |  |  | 24365030 | y | D | EJ | EJ | 13-015 | PR | OB | EJ |  |  |
| 24365035 |  | Proc Windows & Flanges Part A | 98d | 2013-09-03 | 2014-01-31 | 9-130M FS+228d | 243d | 0d | 8/5 M-F w/JLAB Holidays ReBaseline | PROCUREMENT<$50K 60 NO ESCALATION FY14 | 18,066 | FENKER H | 1 | 1 | HOWARD F | 10-069 | 11-026 | 11-046 | 12-012 |  |  | 09-022 | 08-016 | 09-012 | 12-054 |  |  | 24365035 | y | D | EJ | EJ | 13-015 | PR | OB |  |  |  |
| 24365045 |  | Proc Sieve Slit Sys Part A | 192d | 2013-09-03 | 2014-06-13 | 24365030 FS-203d, 24365035 FS-98d, 24365040 FS-140d, 24365032 FS-251d | 344d |  | 8/5 M-F w/JLAB Holidays ReBaseline | PROCUREMENT<$50K 60 NO ESCALATION FY14 | 29,198 | FENKER H | 1 | 1 | HOWARD F | 10-069 | 11-026 | 11-046 | 12-012 |  | 13-006 | 09-022 | 08-016 | 09-012 | 12-054 |  |  | 24365045 | y | D | PE | PE | 13-015 | PR | OB |  |  |  |
| 24365020b |  | Proc Valves & Plumbing and Reliefs Part A Labor FY14 | 42d | 2013-10-01 | 2013-11-27 | 9-130M FS+228d, 24365020a | 358d |  | 8/5 M-F w/JLAB Holidays ReBaseline | MECH ENG [13.55 h] | 1,011.78 | FENKER H | 1 | 1 | HOWARD F | 10-069 | 11-026 | 11-046 | 12-012 | 12-036F | 13-006 | 09-022 |  |  |  |  |  | 24365020 |  | D | EJ | EJ | 13-015 | PR |  |  | 14-001 |  |
| 24365023a |  | Manufacturing Drawings for Vacuum System Parts FY14 | 78d | 2013-10-01 | 2014-01-31 | 24365023, 9-130M FS+228d | 150d | 0d | 8/5 M-F w/JLAB Holidays ReBaseline | MECH DES [159.18 h] | 8,165.93 | FENKER H | 1 | 1 | HOWARD F |  |  |  |  |  | 13-006 |  |  |  |  |  |  | 24365023 |  | H |  | EJ | 13-015 | PR |  |  | 14-001 |  |
| 24365032 |  | Proc Spool & Bellows for All Magnets Part B | 203d | 2013-11-08 | 2014-09-08 | 9-130M FS+228d, 24365023a FS-50d, 24365023 FS-50d | 150d | 0d | 8/5 M-F w/JLAB Holidays ReBaseline | PROCUREMENT>$50K 69 | 20,638 | FENKER H | 1 | 1 | HOWARD F | 10-069 | 11-026 | 11-046 | 12-012 |  | 13-006 | 09-022 |  |  | 12-054 |  |  | 24365030 |  | D | EJ | EJ | 13-015 | PR |  | EJ | 14-001 |  |
| 24365040 |  | Proc Windows & Flanges Part B | 75d | 2013-12-04 | 2014-03-31 | 9-140M FS+44d | 202d | 1d | 8/5 M-F w/JLAB Holidays ReBaseline | PROCUREMENT<$50K 60 | 19,928.99 | FENKER H | 1 | 1 | HOWARD F | 10-069 | 11-026 | 11-046 | 12-012 |  |  | 09-022 | 08-016 | 09-012 | 12-054 |  |  | 24365035 |  | D | EJ | EJ | 13-015 | PR |  |  | 14-001 |  |
| 24365047 |  | Proc Sieve Slit Sys Part B | 192d | 2014-06-13 | 2015-03-26 | 24365035, 24365040, 24365032 FS-60d, 24365030 FS-60d | 153d |  | 8/5 M-F w/JLAB Holidays ReBaseline | PROCUREMENT<$50K 60 NO ESCALATION FY15; PROCUREMENT>$50K 69 NO ESCALATION FY15 | 65,112.86 | FENKER H | 1 | 1 | HOWARD F | 10-069 | 11-026 | 11-046 | 12-012 |  | 13-006 | 09-022 | 08-016 | 09-012 | 12-054 |  |  | 24365045 |  | D | PE | PE | 13-015 | PR |  |  | 14-001 |  |
| 24365050 |  | Fab Slit Controls | 195d | 2014-06-13 | 2015-03-31 | 24365035, 24365032 FS-60d, 24365030 FS-60d, 24365040 | 150d |  | 8/5 M-F w/JLAB Holidays ReBaseline | PROCUREMENT<$50K 60 NO ESCALATION FY15; MECH ENG [80 h] | 18,445.79 | FENKER H | 1 | 1 | HOWARD F | 10-069 | 11-026 | 11-046 | 12-012 |  | 13-006 | 09-022 | 08-016 | 09-012 | 12-054 |  |  | 24365050 |  | S | PE | PE | 13-015 | PR |  |  | 14-001 |  |
|  | 6 | **1.4.3.6.6 CABLING** |  | 2012-01-05 | 2014-07-28 |  |  |  |  |  |  |  |  |  |  |  |  |  |  |  |  |  |  |  |  |  |  |  |  |  |  |  |  |  |  |  |  |  |
| 14366005 |  | Proc HV Cables (CABLING) Original | 18d | 2012-01-05 | 2012-01-31 | 9-120M FS+60d | 417d |  |  | ELEC ENG [2.77 h] | 195.45 | FENKER H | 1 | 1 | HOWARD F | 10-069 | 11-026 | 11-046 |  |  |  |  |  |  |  |  |  |  |  |  |  |  |  |  |  |  |  | 12-022 |
| 14366010 |  | Proc LV & Signal Cables (CABLING) Original | 18d | 2012-01-05 | 2012-01-31 | 9-120M FS+60d | 417d |  |  | ELEC ENG [2.77 h] | 195.45 | FENKER H | 1 | 1 | HOWARD F | 10-069 | 11-026 | 11-046 |  |  |  |  |  |  |  |  |  |  |  |  |  |  |  |  |  |  |  | 12-022 |
| 14366020 |  | Reverse Entry Per CR12-022 | 130d | 2012-02-03 | 2012-08-07 | 9-120M FS+80d | 285d |  |  | ELEC ENG [-5.54 h] | -390.9 | FENKER H | 1 | 1 | HOWARD F | 10-069 | 11-026 | 11-046 |  |  |  |  |  |  |  |  |  |  |  |  |  |  |  |  |  |  |  | 12-022 |
| 14366007 |  | Proc HV Cables (CABLING) Revised per CR12-022 | 130d | 2012-10-01 | 2013-04-12 | 9-130M | 118d |  |  | ELEC ENG [20 h]; PROCUREMENT<$50K 60 | 43,712.72 | FENKER H | 1 | 1 | HOWARD F | 10-069 | 11-026 | 11-046 |  |  |  |  |  |  |  |  |  |  |  |  |  |  |  |  |  |  |  | 12-022 |
| 14366015 |  | Proc LV & Signal Cables (CABLING) Revised per CR12-022 | 130d | 2012-10-01 | 2013-04-12 | 9-130M | 20d | 0d |  | ELEC ENG [20 h]; PROCUREMENT<$50K 60 | 19,566.14 | FENKER H | 1 | 1 | HOWARD F | 10-069 | 11-026 | 11-046 |  |  | 13-006F |  |  |  |  |  |  |  |  |  |  |  |  |  |  |  |  | 12-022 |
| 14366025 |  | Terminate Cables | 43d | 2013-07-02 | 2013-08-30 | 14366015 FS+55d | 20d |  |  | ELEC TECH [112.79 h] | 5,136.46 | FENKER H | 1 | 1 | HOWARD F |  |  |  |  |  | 13-006 |  |  |  |  | 13-014 |  |  |  |  |  |  |  |  |  |  |  |  |
| 14366030 |  | Re-Baseline Actuals Adjustment | 1d | 2013-08-30 | 2013-08-30 | 9-130M FS+227d | 20d |  |  | PROCUREMENT>$50K 69 NO ESCALATION | -61,653.78 | FENKER H | 1 | 1 | HOWARD F |  |  |  |  |  |  |  |  |  |  | 13-014 | ADJ |  |  |  |  |  |  |  |  |  |  |  |
| 24366025 |  | Terminate Cables | 122d | 2014-02-05 | 2014-07-28 | 9-140M FS+80d | 225d | 25d | 8/5 M-F w/JLAB Holidays ReBaseline | ELEC TECH [320 h] | 15,036.8 | FENKER H | 1 | 1 | HOWARD F |  |  |  |  |  | 13-006 |  |  |  |  |  |  | 24366025 |  | U |  | PE | 13-015 | PR |  |  | 14-001 |  |

Notes:
- 14366005: Explanation: "S" History change per CR12-022
- 14366010: Explanation: "S" History change per CR12-022
- 14366020: Explanation: "S" History change per CR12-022
- 14366007: Explanation: "S" History change per CR12-022
- 14366015: Explanation: "S" History change per CR12-022
- 14366025: Explanation: "S" History change per CR12-022
- 24366025: Explanation: "S" History change per CR12-022

| ID | WBS | Activity | Type | Duration | Start | Finish | Predecessors | Total float | Free float | Constraint | Calendar | Resources | Cost | RESP - Responsibility | STRT%COMP for CM EVM | FNSH%COMP for CM EVM | CAM RESPONSIBLE | CR 10-069 | CR 10-076 | CR 11-026 | CR 11-046 | CR 12-012 | CR 12-036 | CR 13-006 | CR 13-014 | ReBaseline Actuals Adjustment | CR 09-022 | CR 10-030 | Milestone Level | CR 11-025 | CR 12-054 | Pat's Code | CR 12-003 | Activities with Steps | CR 08-052 | CR 12-022 | Advance Purchase Plan > 500K | CR 08-016 | CR 09-012 | Original Activity ID Rebaseline | Howard's Code | Over Under Fixed | EVMS Reporting Codes | BOE Procurement | CR 13-015 | Post Rebaseline | Obligated Prior to Rebaseline | BOE Labor | BOE Expenses |
| --- | --- | --- | --- | --- | --- | --- | --- | --- | --- | --- | --- | --- | --- | --- | --- | --- | --- | --- | --- | --- | --- | --- | --- | --- | --- | --- | --- | --- | --- | --- | --- | --- | --- | --- | --- | --- | --- | --- | --- | --- | --- | --- | --- | --- | --- | --- | --- | --- | --- |
|  | 7 | **1.4.3.6.7 SOS PIVOT MODIFICATION** |  |  | 2011-11-02 | 2013-08-30 |  |  |  |  |  |  |  |  |  |  |  |  |  |  |  |  |  |  |  |  |  |  |  |  |  |  |  |  |  |  |  |  |  |  |  |  |  |  |  |  |  |  |  |
| 14367005 |  | Proc Parts for SHMS Pivot Connection (SOS PIVOT MOD) |  | 130d | 2011-11-02 | 2012-05-15 | 9-120M FS+22d, 2-02M FS-130d | 231d | 211d |  |  | MECH ENG [40 h]; MECH DES [40 h] | 4,731.6 | FENKER H | 1 | 1 | HOWARD F | 10-069 | 10-076 | 11-026 | 11-046 | 12-012 | 12-036F | 13-006F |  |  |  |  |  |  |  |  |  |  |  |  |  |  |  |  |  |  |  |  |  |  |  |  |  |
| 14367010 |  | Re-Baseline Actuals Adjustment |  | 1d | 2013-08-30 | 2013-08-30 | 9-130M FS+227d | 20d |  |  |  | PROCUREMENT>$50K 69 NO ESCALATION | -4,731.59 | FENKER H | 1 | 1 | HOWARD F |  |  |  |  |  |  |  | 13-014 | ADJ |  |  |  |  |  |  |  |  |  |  |  |  |  |  |  |  |  |  |  |  |  |  |  |
|  | 8 | **1.4.3.6.8 INSTALLATION** |  |  | 2011-05-13 | 2015-12-23 |  |  |  |  |  |  |  |  |  |  |  |  |  |  |  |  |  |  |  |  |  |  |  |  |  |  |  |  |  |  |  |  |  |  |  |  |  |  |  |  |  |  |  |
| 14368170 |  | Remove Remaining HKS/HES Components |  | 50d | 2011-05-13 | 2011-07-25 | 4A-01M | 78d |  |  |  |  |  | FENKER H | 1 | 1 | HOWARD F |  |  |  |  |  |  |  |  |  | 09-022 | 10-030 |  |  |  |  |  |  |  |  |  |  |  |  |  |  |  |  |  |  |  |  |  |
| 14368171 |  | Strip Clean The SOS: Hoses, Cable & Shielding |  | 110d | 2011-05-13 | 2011-10-18 | 4A-01M | 18d |  |  |  |  |  | FENKER H | 1 | 1 | HOWARD F |  |  |  |  |  |  |  |  |  | 09-022 | 10-030 |  |  |  |  |  |  |  |  |  |  |  |  |  |  |  |  |  |  |  |  |  |
| 14368005 |  | Prep for safety Review for Installtn Plans |  | 25d | 2011-11-02 | 2011-12-08 | 9-120M FS+22d | 157d | 0d |  |  | ELEC ENG [160 h]; MECH DES [320 h]; MECH ENG [160 h] | 37,923.2 | FENKER H | 1 | 1 | HOWARD F |  |  |  | 11-046 |  |  |  |  |  | 09-022 |  |  |  |  |  |  |  |  |  |  |  |  |  |  |  |  |  |  |  |  |  |  |
| 14368010M |  | Comp safety Review for Installtn Plans | milestone | 0d | 2011-12-08 | 2011-12-08 | 14368005 | 157d | 103d |  |  |  |  | FENKER H | 1 | 1 | HOWARD F |  |  |  | 11-046 |  |  |  |  |  |  |  | 6 |  |  |  |  |  |  |  |  |  |  |  |  |  |  |  |  |  |  |  |  |
| 14368172 |  | Radiation Cooldown |  | 20d | 2012-05-14 | 2012-06-12 | 2-02M | 20d | 0d |  |  |  |  | FENKER H | 1 | 1 | HOWARD F | 10-069 |  | 11-026 | 11-046 | 12-012 | 12-036F | 13-006F |  |  | 09-022 |  |  | 11-025 | 12-054F |  |  |  |  |  |  |  |  |  |  |  |  |  |  |  |  |  |  |
| 14368176 |  | Reroute HMS Cableways to Clear SHMS |  | 60d | 2012-05-14 | 2012-08-07 | 2-07M, 2-02M | 178d | 158d |  |  | MECH TECH [80 h]; PROCUREMENT<$50K 60; MECH DES [80 h] | 18,056.98 | FENKER H | 1 | 1 | HOWARD F | 10-069 |  | 11-026 | 11-046 | 12-012 | 12-036F | 13-006F |  |  | 09-022 |  |  | 11-025 |  |  |  |  |  |  |  |  |  |  |  |  |  |  |  |  |  |  |  |
| 14368180 |  | Restore HaLL C and ESR Cryo To Base Config. |  | 10d | 2012-05-14 | 2012-05-25 | 2-02M | 275d | 0d |  |  |  |  | FENKER H | 1 | 1 | HOWARD F | 10-069 |  | 11-026 | 11-046 | 12-012 | 12-036F |  |  |  | 09-022 |  |  |  |  | Pat | 12-003 |  |  |  |  |  |  |  |  |  |  |  |  |  |  |  |  |
| 14368425 |  | Install QR Magnets (Notebook) |  | 50d | 2012-05-16 | 2012-07-26 | 14352005 | 846d |  |  |  | MECH DES [80 h]; MECH TECH [160 h] | 10,964 | FENKER H | 1 | 1 | HOWARD F | 10-069 |  |  | 11-046 | 12-012 |  |  |  |  |  |  |  |  |  |  |  | NB |  |  |  |  |  |  |  |  |  |  |  |  |  |  |  |
| 14368172a |  | Qweak Post Run Alignment Survey |  | 10d | 2012-05-29 | 2012-06-12 | 14368172 FS-10d, 2-02M | 20d | 0d |  |  |  |  | FENKER H | 1 | 1 | HOWARD F | 10-069 |  | 11-026 | 11-046 | 12-012 | 12-036F | 13-006F |  |  | 09-022 |  |  | 11-025 | 12-054F |  |  |  |  |  |  |  |  |  |  |  |  |  |  |  |  |  |  |
| 14368182M |  | Cryogens Available from ESR or CHL | milestone | 0d | 2012-05-29 | 2012-05-29 | 9-120M FS+160d | 275d | 0d |  |  |  |  | FENKER H | 1 | 1 | HOWARD F | 10-069 |  | 11-026 | 11-046 | 12-012 | 12-036F |  |  |  | 09-022 |  |  |  |  | Pat | 12-003 |  |  |  |  |  |  |  |  |  |  |  |  |  |  |  |  |
| 14368185 |  | Cool Down HMS Dipole |  | 5d | 2012-05-29 | 2012-06-05 | 14368182M, 14368180 | 275d | 0d |  |  |  |  | FENKER H | 1 | 1 | HOWARD F | 10-069 |  | 11-026 | 11-046 | 12-012 | 12-036F |  |  |  | 09-022 |  |  |  |  | Pat | 12-003 |  |  |  |  |  |  |  |  |  |  |  |  |  |  |  |  |
| 14368190 |  | Cool Down HMS Q1 |  | 10d | 2012-06-06 | 2012-06-19 | 14368185 | 275d | 0d |  |  |  |  | FENKER H | 1 | 1 | HOWARD F | 10-069 |  | 11-026 | 11-046 | 12-012 | 12-036F |  |  |  | 09-022 |  |  |  |  | Pat | 12-003 |  |  |  |  |  |  |  |  |  |  |  |  |  |  |  |  |
| 14368210 |  | Prepare LCW for SHMS DCPS Testing |  | 10d | 2012-06-06 | 2012-06-19 | 14368185, 14368207 FS-171d | 297d | 2d |  |  | SUPPLIES & MATERIALS; MECH TECH [160 h]; MECH ENG [80 h] | 18,044.09 | FENKER H | 1 | 1 | HOWARD F | 10-069 |  | 11-026 | 11-046 | 12-012 | 12-036F |  |  |  | 09-022 |  |  |  |  | Pat | 12-003 |  |  |  |  |  |  |  |  |  |  |  |  |  |  |  |  |
| 14368215 |  | Prepare AC Power for SHMS DCPS Testing |  | 10d | 2012-06-06 | 2012-06-19 | 14368185 | 297d | 2d |  |  | ELEC TECH [160 h]; ELEC ENG [80 h]; SUPPLIES & MATERIALS | 23,353.78 | FENKER H | 1 | 1 | HOWARD F | 10-069 |  | 11-026 | 11-046 | 12-012 | 12-036F |  |  |  | 09-022 |  |  |  |  | Pat | 12-003 |  |  |  |  |  |  |  |  |  |  |  |  |  |  |  |  |
| 14368173 |  | Disconnect & Remove Qweak Girder |  | 5d | 2012-06-13 | 2012-06-19 | 3P-04M, 14368172 | 208d | 188d |  |  |  |  | FENKER H | 1 | 1 | HOWARD F | 10-069 | 10-076 | 11-026 | 11-046 | 12-012 | 12-036F | 13-006F |  |  | 09-022 |  |  |  |  |  |  |  |  |  |  |  |  |  |  |  |  |  |  |  |  |  |  |
| 14368174 |  | Dismantle & Remove Qweak Electronics Bunker |  | 5d | 2012-06-13 | 2012-06-19 | 14368172a, 14368172 FS-20d | 20d | 0d |  |  |  |  | FENKER H | 1 | 1 | HOWARD F | 10-069 |  | 11-026 | 11-046 | 12-012 | 12-036F | 13-006F |  |  | 09-022 |  |  | 11-025 | 12-054F |  |  |  |  |  |  |  |  |  |  |  |  |  |  |  |  |  |  |
| 14368174a |  | Install SOS Rails, Move SOS and Remove doors and door frame |  | 10d | 2012-06-20 | 2012-07-03 | 14368174 | 58d | 0d |  |  |  |  | FENKER H | 1 | 1 | HOWARD F | 10-069 |  |  | 11-046 | 12-012 | 12-036F | 13-006F |  |  | 09-022 |  |  | 11-025 |  |  |  |  |  |  |  |  |  |  |  |  |  |  |  |  |  |  |  |
| 14368174h |  | Remove HKS Dummy weight |  | 2d | 2012-06-20 | 2012-06-21 | 14368174 | 20d | 0d |  |  |  |  | FENKER H | 1 | 1 | HOWARD F | 10-069 |  |  | 11-046 | 12-012 | 12-036F | 13-006F |  |  | 09-022 |  |  | 11-025 | 12-054F |  |  |  |  |  |  |  |  |  |  |  |  |  |  |  |  |  |  |
| 14368195 |  | Cool Down HMS Q2 |  | 10d | 2012-06-20 | 2012-07-03 | 14368190 | 275d | 0d |  |  |  |  | FENKER H | 1 | 1 | HOWARD F | 10-069 |  | 11-026 | 11-046 | 12-012 | 12-036F |  |  |  | 09-022 |  |  |  |  | Pat | 12-003 |  |  |  |  |  |  |  |  |  |  |  |  |  |  |  |  |
| 14368220 |  | Connect HMS Q1 to SHMS DCPS #1 |  | 2d | 2012-06-20 | 2012-06-21 | 14368190, 14315075 | 295d | 0d | start on or after 2011-05-26 |  | ELEC TECH [32 h] | 1,412.16 | FENKER H | 1 | 1 | HOWARD F | 10-069 |  | 11-026 | 11-046 | 12-012 | 12-036F |  |  |  | 09-022 |  |  |  |  | Pat | 12-003 |  |  |  |  |  |  |  |  |  |  |  |  |  |  |  |  |
| 14368174j |  | Remove Qweak cableling and trays |  | 5d | 2012-06-22 | 2012-06-28 | 14368174h | 20d | 0d |  |  |  |  | FENKER H | 1 | 1 | HOWARD F | 10-069 |  |  | 11-046 | 12-012 | 12-036F | 13-006F |  |  | 09-022 |  |  | 11-025 | 12-054F |  |  |  |  |  |  |  |  |  |  |  |  |  |  |  |  |  |  |
| 14368225 |  | Test Power Supply DCPS #1 |  | 3d | 2012-06-22 | 2012-06-26 | 14368220, 14368215, 14368210 | 295d | 0d |  |  | MECH ENG [48 h] | 3,365.76 | FENKER H | 1 | 1 | HOWARD F | 10-069 |  | 11-026 | 11-046 | 12-012 | 12-036F |  |  |  | 09-022 |  |  |  |  | Pat | 12-003 |  |  |  |  |  |  |  |  |  |  |  |  |  |  |  |  |
| 14368230 |  | Connect HMS Q1 to SHMS DCPS #2 |  | 2d | 2012-06-27 | 2012-06-28 | 14368225 | 295d | 0d |  |  | ELEC TECH [32 h] | 1,412.16 | FENKER H | 1 | 1 | HOWARD F | 10-069 |  | 11-026 | 11-046 | 12-012 | 12-036F |  |  |  | 09-022 |  |  |  |  | Pat | 12-003 |  |  |  |  |  |  |  |  |  |  |  |  |  |  |  |  |
| 14368174k |  | Remove Qweak Region 3 Shield Hut |  | 12d | 2012-06-29 | 2012-07-16 | 14368174j | 20d | 0d |  |  |  |  | FENKER H | 1 | 1 | HOWARD F | 10-069 |  |  | 11-046 | 12-012 | 12-036F | 13-006F |  |  | 09-022 |  |  | 11-025 | 12-054F |  |  |  |  |  |  |  |  |  |  |  |  |  |  |  |  |  |  |
| 14368235 |  | Test Power Supply DCPS #2 |  | 3d | 2012-06-29 | 2012-07-03 | 14368230 | 295d | 194d |  |  | MECH ENG [48 h] | 3,365.76 | FENKER H | 1 | 1 | HOWARD F | 10-069 |  | 11-026 | 11-046 | 12-012 | 12-036F |  |  |  | 09-022 |  |  |  |  | Pat | 12-003 |  |  |  |  |  |  |  |  |  |  |  |  |  |  |  |  |
| 14368174b |  | Remove SOS Hydraulic Cylinders and supports |  | 10d | 2012-07-04 | 2012-07-17 | 14368174a | 58d | 0d |  |  |  |  | FENKER H | 1 | 1 | HOWARD F | 10-069 |  |  | 11-046 | 12-012 | 12-036F | 13-006F |  |  | 09-022 |  |  | 11-025 |  |  |  |  |  |  |  |  |  |  |  |  |  |  |  |  |  |  |  |
| 14368200 |  | Cool Down HMS Q3 |  | 10d | 2012-07-04 | 2012-07-17 | 14368195 | 275d | 0d |  |  |  |  | FENKER H | 1 | 1 | HOWARD F | 10-069 |  | 11-026 | 11-046 | 12-012 | 12-036F |  |  |  | 09-022 |  |  |  |  | Pat | 12-003 |  |  |  |  |  |  |  |  |  |  |  |  |  |  |  |  |
| 14368174n |  | Remove Qweak Region 3 Detectors and support structures |  | 15d | 2012-07-17 | 2012-08-06 | 14368174k | 20d | 0d |  |  |  |  | FENKER H | 1 | 1 | HOWARD F | 10-069 |  |  | 11-046 | 12-012 | 12-036F | 13-006F |  |  | 09-022 |  |  | 11-025 | 12-054F |  |  |  |  |  |  |  |  |  |  |  |  |  |  |  |  |  |  |
| 14368174c |  | Move SOS Back and Saw cut and remove concrete |  | 15d | 2012-07-18 | 2012-08-07 | 14368174b | 58d | 32d |  |  |  |  | FENKER H | 1 | 1 | HOWARD F | 10-069 |  |  | 11-046 | 12-012 | 12-036F | 13-006F |  |  | 09-022 |  |  | 11-025 |  |  |  |  |  |  |  |  |  |  |  |  |  |  |  |  |  |  |  |
| 14368205 |  | Comission HMS Dipole at 3000 amps |  | 10d | 2012-07-18 | 2012-07-31 | 14368200 | 275d | 174d |  |  |  |  | FENKER H | 1 | 1 | HOWARD F | 10-069 |  | 11-026 | 11-046 | 12-012 | 12-036F |  |  |  | 09-022 |  |  |  |  | Pat | 12-003 |  |  |  |  |  |  |  |  |  |  |  |  |  |  |  |  |
| 14368174p |  | Remove QTOR Magnet |  | 10d | 2012-08-07 | 2012-08-20 | 14368174n | 20d | 0d |  |  |  |  | FENKER H | 1 | 1 | HOWARD F | 10-069 |  |  | 11-046 | 12-012 | 12-036F | 13-006F |  |  | 09-022 |  |  | 11-025 | 12-054F |  |  |  |  |  |  |  |  |  |  |  |  |  |  |  |  |  |  |
| 14368174q |  | Remove Qweak shield wall and beam dump sections |  | 5d | 2012-08-21 | 2012-08-27 | 14368174p | 20d | 0d |  |  |  |  | FENKER H | 1 | 1 | HOWARD F | 10-069 |  |  | 11-046 | 12-012 | 12-036F | 13-006F |  |  | 09-022 |  |  | 11-025 | 12-054F |  |  |  |  |  |  |  |  |  |  |  |  |  |  |  |  |  |  |
| 14368174r |  | Remove Qweak regions 1 and 2 |  | 13d | 2012-08-28 | 2012-09-14 | 14368174q | 20d | 0d |  |  |  |  | FENKER H | 1 | 1 | HOWARD F | 10-069 |  |  | 11-046 | 12-012 | 12-036F | 13-006F |  |  | 09-022 |  |  | 11-025 | 12-054F |  |  |  |  |  |  |  |  |  |  |  |  |  |  |  |  |  |  |
| 14368174s |  | Remove Qweak cryo target complete |  | 5d | 2012-09-17 | 2012-09-21 | 14368174r | 20d | 0d |  |  |  |  | FENKER H | 1 | 1 | HOWARD F | 10-069 |  |  | 11-046 | 12-012 | 12-036F | 13-006F |  |  | 09-022 |  |  | 11-025 | 12-054F |  |  |  |  |  |  |  |  |  |  |  |  |  |  |  |  |  |  |
| 14368174d |  | Remove SOS Dipole |  | 5d | 2012-09-24 | 2012-09-28 | 14368174c, 14368174s | 26d | 0d |  |  |  |  | FENKER H | 1 | 1 | HOWARD F | 10-069 |  |  | 11-046 | 12-012 | 12-036F | 13-006F |  |  | 09-022 |  |  | 11-025 |  |  |  |  |  |  |  |  |  |  |  |  |  |  |  |  |  |  |  |
| 14368174t |  | Remove all remaining 9.5" concrete pads |  | 10d | 2012-09-24 | 2012-10-05 | 14368174s | 20d | 0d |  |  |  |  | FENKER H | 1 | 1 | HOWARD F | 10-069 |  |  | 11-046 | 12-012 | 12-036F | 13-006F |  |  | 09-022 |  |  | 11-025 | 12-054F |  |  |  |  |  |  |  |  |  |  |  |  |  |  |  |  |  |  |
| 14368325 |  | Install Rails of Supprt Struct |  | 31d | 2012-11-19 | 2013-01-10 | 14368174t FS+30d, 14368322 FS-40d, 14362015 | 20d | 0d |  |  | PLABOR; MECH TECH [80 h]; SUPPLIES & MATERIALS; MSHOP | 44,790.42 | FENKER H | 1 | 1 | HOWARD F | 10-069 |  |  | 11-046 | 12-012 | 12-036F | 13-006F |  |  | 09-022 |  |  |  | 12-054 |  |  |  | 08-052 |  |  |  |  |  |  |  |  |  |  |  |  |  |  |
| 14368383 |  | Procure SHMS Steel Platforms and Stairs |  | 99d | 2012-12-03 | 2013-04-30 | 9-130M FS+43d | 106d |  |  |  | PROCUREMENT>$50K 69 | 87,898.23 | FENKER H | 1 | 1 | HOWARD F | 10-069 |  |  | 11-046 | 12-012 | 12-036F |  |  |  | 09-022 |  |  |  |  |  |  |  | 08-052 | 12-022 |  |  |  |  |  |  |  |  |  |  |  |  |  |
| 14368207 |  | Complete Readiness Review for SHMS DCPS Testing |  | 30d | 2013-01-02 | 2013-02-13 | 9-130M FS+59d | 297d | 0d |  |  | MECH ENG [40 h]; MECH DES [40 h]; SCIENTIST [40 h] | 7,797.2 | FENKER H | 1 | 1 | HOWARD F |  |  |  |  |  |  | 13-006 |  |  |  |  |  |  |  |  |  |  |  |  |  |  |  |  |  |  |  |  |  |  |  |  |  |
| 14368322 |  | Re-Establish Hall-C Alignment Network Prior to SHMS Assy |  | 5d | 2013-01-02 | 2013-01-08 | 14368174t FS+54d | 31d | 11d |  |  | MECH TECH [80 h] | 3,668.8 | FENKER H | 1 | 1 | HOWARD F |  |  |  |  |  |  | 13-006 |  |  |  |  |  |  |  |  |  |  |  |  | APP |  |  |  |  |  |  |  |  |  |  |  |  |
| 14368174f |  | Saw cut and remove remaining SOS concrete |  | 3d | 2013-02-15 | 2013-02-20 | 14368174d FS+90d | 26d | 0d |  |  |  |  | FENKER H | 1 | 1 | HOWARD F | 10-069 |  |  | 11-046 | 12-012 | 12-036F | 13-006 |  |  | 09-022 |  |  | 11-025 |  |  |  |  |  |  |  |  |  |  |  |  |  |  |  |  |  |  |  |
| 14368174g |  | Remove SOS Chassis , rails and pivot bearing |  | 17d | 2013-02-21 | 2013-03-15 | 14368174f | 26d | 6d |  |  |  |  | FENKER H | 1 | 1 | HOWARD F | 10-069 |  |  | 11-046 | 12-012 | 12-036F | 13-006 |  |  | 09-022 |  |  | 11-025 |  |  |  |  |  |  |  |  |  |  |  |  |  |  |  |  |  |  |  |
| 14368327 |  | Check Rail Alignment |  | 1d | 2013-02-21 | 2013-02-21 | 14368325 FS+27d | 707d | 0d |  |  | MECH TECH [16 h] | 733.76 | FENKER H | 1 | 1 | HOWARD F |  |  |  |  |  |  | 13-006 |  |  |  |  |  |  |  |  |  |  |  |  |  |  |  |  |  |  |  |  |  |  |  |  |  |
| 14368335M |  | Central Rails for SHMS Installed (SHIELD HOUSE) | milestone | 0d | 2013-02-22 | 2013-02-22 | 14368327, 14368325 | 707d |  |  |  |  |  | FENKER H | 1 | 1 | HOWARD F | 10-069 |  |  | 11-046 |  |  | 13-006 |  |  | 09-022 |  | 6 |  | 12-054 |  |  |  | 08-052 |  |  |  |  |  |  |  |  |  |  |  |  |  |  |
| 14368015 |  | Install Pivot for SHMS |  | 5d | 2013-03-26 | 2013-04-01 | 14367005, 14368173, 14368174g, 14362075a, 14368325 FS+50d, 14362075b, 3P-07M | 20d | 0d |  |  | MECH ENG [40 h]; MECH DES [40 h]; PROCUREMENT<$50K 60; MECH TECH [80 h]; PLABOR | 18,551.6 | FENKER H | 1 | 1 | HOWARD F | 10-069 | 10-076 | 11-026 | 11-046 | 12-012 | 12-036F | 13-006 |  |  | 09-022 |  |  |  | 12-054 |  |  |  |  |  |  |  |  |  |  |  |  |  |  |  |  |  |  |
| 14368020 |  | Move Pre-Fab Compnts into Hall with road crane |  | 3d | 2013-04-02 | 2013-04-04 | 14362050, 14368174t, 14362030, 14368176, 14362035, 14362055, 14362035a, 14362020, 14368015, 14362015, 14362040, 14362045, 14362025, 14362050a | 20d | 0d |  |  | MECH DES [40 h]; MECH TECH [80 h]; PROCUREMENT<$50K 60; PROCUREMENT>$50K 69 | 41,657.2 | FENKER H | 1 | 1 | HOWARD F | 10-069 |  | 11-026 | 11-046 | 12-012 | 12-036F | 13-006 |  |  | 09-022 |  |  | 11-025 | 12-054 |  |  |  |  |  | APP | 08-016 | 09-012 |  |  |  |  |  |  |  |  |  |  |
| 14368175 |  | Ccan and platform removal |  | 30d | 2013-04-02 | 2013-05-13 | 14368020 FS-3d | 20d | 0d |  |  | MECH DES [240 h]; MECH TECH [880 h] | 52,287.2 | FENKER H | 1 | 1 | HOWARD F | 10-069 |  | 11-026 | 11-046 | 12-012 | 12-036F | 13-006 |  |  | 09-022 |  |  | 11-025 | 12-054 |  |  |  |  |  |  |  |  |  |  |  |  |  |  |  |  |  |  |
| 14368240 |  | Connect HMS Dipole to SHMS DCPS #3 |  | 2d | 2013-04-17 | 2013-04-18 | 14315085 FS+110d, 14368235, 14368205 | 101d | 0d |  |  | ELEC TECH [32 h] | 1,457.28 | FENKER H | 1 | 1 | HOWARD F | 10-069 |  | 11-026 | 11-046 | 12-012 | 12-036F |  |  |  | 09-022 |  |  |  | 12-054 | Pat | 12-003 |  |  |  |  |  |  |  |  |  |  |  |  |  |  |  |  |
| 14368245 |  | Test Power Supply DCPS #3 |  | 3d | 2013-04-19 | 2013-04-23 | 14368240 | 101d | 0d |  |  | MECH ENG [48 h] | 3,473.28 | FENKER H | 1 | 1 | HOWARD F | 10-069 |  | 11-026 | 11-046 | 12-012 | 12-036F |  |  |  | 09-022 |  |  |  | 12-054 | Pat | 12-003 |  |  |  |  |  |  |  |  |  |  |  |  |  |  |  |  |
| 14368250 |  | Connect HMS Dipole to SHMS DCPS #4 |  | 2d | 2013-04-24 | 2013-04-25 | 14368245 | 101d | 0d |  |  | ELEC TECH [32 h] | 1,457.28 | FENKER H | 1 | 1 | HOWARD F | 10-069 |  | 11-026 | 11-046 | 12-012 | 12-036F |  |  |  | 09-022 |  |  |  | 12-054 | Pat | 12-003 |  |  |  |  |  |  |  |  |  |  |  |  |  |  |  |  |
| 14368255 |  | Test Power Supply DCPS #4 |  | 3d | 2013-04-26 | 2013-04-30 | 14368250 | 101d | 0d |  |  | MECH ENG [48 h] | 3,473.28 | FENKER H | 1 | 1 | HOWARD F | 10-069 |  | 11-026 | 11-046 | 12-012 | 12-036F |  |  |  | 09-022 |  |  |  | 12-054 | Pat | 12-003 |  |  |  |  |  |  |  |  |  |  |  |  |  |  |  |  |
| 14368260 |  | Connect HMS Dipole to SHMS DCPS #5 |  | 2d | 2013-05-01 | 2013-05-02 | 14368255 | 101d | 0d |  |  | ELEC TECH [32 h] | 1,457.28 | FENKER H | 1 | 1 | HOWARD F | 10-069 |  | 11-026 | 11-046 | 12-012 | 12-036F |  |  |  | 09-022 |  |  |  | 12-054 | Pat | 12-003 |  |  |  |  |  |  |  |  |  |  |  |  |  |  |  |  |
| 14368265 |  | Test Power Supply DCPS #5 |  | 3d | 2013-05-03 | 2013-05-07 | 14368260 | 101d |  |  |  | MECH ENG [48 h] | 3,473.28 | FENKER H | 1 | 1 | HOWARD F | 10-069 |  | 11-026 | 11-046 | 12-012 | 12-036F |  |  |  | 09-022 |  |  |  | 12-054 | Pat | 12-003 |  |  |  |  |  |  |  |  |  |  |  |  |  |  |  |  |
| 14368330 |  | Assemble Main Carriage of Supprt Struct |  | 60d | 2013-05-14 | 2013-08-07 | 14362060, 14368175, 14368020, 14362011 FS-125d | 20d | 0d |  |  | MECH ENG [200 h]; MSHOP; SUPPLIES & MATERIALS; PLABOR; MECH TECH [1040 h]; PROCUREMENT<$50K 60; MECH DES [320 h]; PROCUREMENT>$50K 69 | 621,682.34 | FENKER H | 1 | 1 | HOWARD F | 10-069 |  |  | 11-046 | 12-012 | 12-036F | 13-006 |  |  | 09-022 |  |  |  | 12-054 |  |  |  | 08-052 |  | APP | 08-016 | 09-012 |  |  |  |  |  |  |  |  |  |  |
| 14368115 |  | Prep for Vac & pressure systems Safety Review |  | 10d | 2013-06-25 | 2013-07-09 | 9-130M FS+180d | 58d | 0d |  |  | MECH ENG [80 h] | 5,788.8 | FENKER H | 1 | 1 | HOWARD F | 10-069 |  | 11-026 | 11-046 | 12-012 | 12-036F |  |  |  |  |  |  |  | 12-054 |  |  |  |  |  |  |  |  |  |  |  |  |  |  |  |  |  |  |
| 14368280LOE |  | Installation Management P1 |  | 44d | 2013-07-01 | 2013-08-30 | 9-130M FS+184d | 20d |  |  |  | SCIENTIST [226.88 h] | 16,530.48 | FENKER H | 1 | 1 | HOWARD F | 10-069 |  | 11-026 | 11-046 |  |  |  | 13-014 |  |  |  |  |  |  |  |  |  |  |  |  |  |  |  |  |  |  |  |  |  |  |  |  |
| 14368120M |  | Comp safety Review of vacuum & pressure Vessel systems Implementn | milestone | 0d | 2013-07-09 | 2013-07-09 | 14368115 | 58d |  |  |  |  |  | FENKER H | 1 | 1 | HOWARD F | 10-069 |  | 11-026 | 11-046 | 12-012 | 12-036F |  |  |  |  |  | 6 |  | 12-054 |  |  |  |  |  |  |  |  |  |  |  |  |  |  |  |  |  |  |
| 14368027 |  | Install Wheels and Bogies |  | 10d | 2013-08-08 | 2013-08-21 | 14362050, 14368330, 14362050a | 27d |  |  |  | MECH DES [160 h]; MECH ENG [80 h]; MECH TECH [216 h]; PROCUREMENT<$50K 60; PROCUREMENT>$50K 69 | 83,648.16 | FENKER H | 1 | 1 | HOWARD F | 10-069 |  |  | 11-046 | 12-012 | 12-036F | 13-006 |  |  | 09-022 |  |  | 11-025 | 12-054 |  |  |  |  |  | APP | 08-016 | 09-012 |  |  |  |  |  |  |  |  |  |  |
| 14368028 |  | Construct REAR Access Platform & Shield Wall |  | 17d | 2013-08-08 | 2013-08-30 | 14368330 | 20d |  |  |  | MECH DES [90.67 h]; MECH TECH [113.33 h]; PROCUREMENT<$50K 60; MECH ENG [45.33 h] | 12,984.66 | FENKER H | 1 | 1 | HOWARD F | 10-069 |  | 11-026 | 11-046 |  |  | 13-006 | 13-014 |  | 09-022 |  |  | 11-025 | 12-054 |  |  |  |  |  | APP |  |  |  |  |  |  |  |  |  |  |  |  |
| 14368333 |  | Install Cryo Boom Support |  | 2d | 2013-08-08 | 2013-08-09 | 14368330, 14364050 | 35d |  |  |  | MECH DES [80 h]; MECH TECH [160 h]; PROCUREMENT<$50K 60 | 26,314.4 | FENKER H | 1 | 1 | HOWARD F | 10-069 |  |  | 11-046 | 12-012 | 12-036F | 13-006 |  |  | 09-022 |  |  |  | 12-054 |  |  |  | 08-052 | 12-022 | APP | 08-016 | 09-012 |  |  |  |  |  |  |  |  |  |  |
| 14368510 |  | Re-Baseline Actuals Adjustment |  | 1d | 2013-08-30 | 2013-08-30 | 9-130M FS+227d | 20d |  |  |  | PROCUREMENT>$50K 69 NO ESCALATION | -370,343.31 | FENKER H | 1 | 1 | HOWARD F |  |  |  |  |  |  |  | 13-014 | ADJ |  |  |  |  |  |  |  |  |  |  |  |  |  |  |  |  |  |  |  |  |  |  |  |
| 24368040 |  | Procure SHMS Steel Platforms and Stairs (Box O Parts) Part A |  | 77d | 2013-09-03 | 2013-12-20 | 9-130M FS+228d | 285d | 30d |  | 8/5 M-F w/JLAB Holidays ReBaseline | PROCUREMENT<$50K 60 NO ESCALATION FY14 | 2,266 | FENKER H | 1 | 1 | HOWARD F | 10-069 |  |  | 11-046 | 12-012 | 12-036F | 13-006F |  |  | 09-022 |  |  |  |  |  |  |  | 08-052 | 12-022 |  |  |  | 24368383 | 1 | y | D | EJ | 13-015 | PR | OB |  |  |
| 24368050 |  | Install SHMS Steel Procurement |  | 20d | 2013-09-03 | 2013-09-30 | 9-130M FS+228d | 189d | 0d |  | 8/5 M-F w/JLAB Holidays ReBaseline | PROCUREMENT>$50K 69; PROCUREMENT<$50K 60 | 174,707.4 | FENKER H | 1 | 1 | HOWARD F | 10-069 | 10-076 | 11-026 | 11-046 | 12-012 | 12-036F | 13-006 |  |  | 09-022 |  |  |  | 12-054 |  |  |  |  |  |  |  |  | 24368015 | 1 | y | D | EV | 13-015 | PR | OB | EJ |  |
| 24368052 |  | Align Wheels and Bogies on Support Structure |  | 4d | 2013-09-03 | 2013-09-06 | 24368050 FS-20d | 567d |  |  | 8/5 M-F w/JLAB Holidays ReBaseline | MECH TECH [80 h] | 3,668.8 | FENKER H | 1 | 1 | HOWARD F | 10-069 | 10-076 | 11-026 | 11-046 | 12-012 | 12-036F | 13-006 |  |  | 09-022 |  |  |  | 12-054 |  |  |  |  |  |  |  |  | 24368052 | 1 |  | H | EV | 13-015 | PR |  | EJ |  |
| 24368065 |  | Forming and Pouring Work for Concrete - Procurement |  | 62d | 2013-09-03 | 2013-11-27 | 9-130M FS+228d, 24368050 FS-20d | 189d | 0d |  | 8/5 M-F w/JLAB Holidays ReBaseline | MECH DES; MECH ENG; PROCUREMENT<$50K 60 NO ESCALATION FY14; PROCUREMENT>$50K 69 NO ESCALATION FY14 | 309,508.2 | FENKER H | 1 | 1 | HOWARD F | 10-069 |  |  | 11-046 | 12-012 | 12-036 | 13-006 |  |  | 09-022 |  |  | 11-025 | 12-054 |  |  |  | 08-052 |  | APP | 08-016 | 09-012 | 24368355 | 2 | y | D | EJ | 13-015 | PR | OB | EJ | EJ |
| 24368065a |  | Forming and Pouring Work for Concrete - Labor FY13 |  | 20d | 2013-09-03 | 2013-09-30 | 9-130M FS+228d, 24368050 FS-20d | 189d | 0d |  | 8/5 M-F w/JLAB Holidays ReBaseline | MECH DES [51.61 h]; MECH ENG [25.81 h] | 4,433.07 | FENKER H | 1 | 1 | HOWARD F | 10-069 |  |  | 11-046 | 12-012 | 12-036 | 13-006 |  |  | 09-022 |  |  | 11-025 | 12-054 |  |  |  | 08-052 |  | APP | 08-016 | 09-012 | 24368355 | 2 |  | D | EJ | 13-015 | PR |  | EJ | EJ |

Notes:
- 14368425: Explanation: Budget contains 2 weeks of Survey & Alignment Tech in / the Mech Tech Budget. 12Aug2010 PMC
- 14368027: Explanation: Removed 13.0 weeks each of ME and MT to keep CR11-046 a Level / 5
- 14368028: Entry Criteria: Ext Pred: COMPLETE MAGNET CONTRACT

| ID | Activity | Type | Duration | Start | Finish | Predecessors | Total float | Free float | Calendar | Resources | Cost | Original Activity ID Rebaseline | Howard's Code | Over Under Fixed | RESP - Responsibility | STRT%COMP for CM EVM | FNSH%COMP for CM EVM | Advance Purchase Plan > 500K | EVMS Reporting Codes | CAM RESPONSIBLE | CR 08-052 | CR 09-022 | CR 10-069 | CR 11-025 | CR 11-046 | CR 12-012 | CR 12-036 | CR 12-054 | CR 13-006 | BOE Procurement | BOE Labor | BOE Expenses | CR 13-015 | Post Rebaseline | Obligated Prior to Rebaseline | CR 10-076 | BOE NOTES | CR 11-026 | Pat's Code | CR 12-003 | CR 12-022 | CR 14-001 | CR 08-016 | CR 09-012 | Activities with Steps | Milestone Level | 12 GEV MAJOR PROCUREMENT CATAGORY | CR 10-025 | CR 07-024 | CR 07-034 | CR 08-048 | CR 11-017 | Inter Project Link (IPL) | CR 10-063 | CR 10-074 |
| --- | --- | --- | --- | --- | --- | --- | --- | --- | --- | --- | --- | --- | --- | --- | --- | --- | --- | --- | --- | --- | --- | --- | --- | --- | --- | --- | --- | --- | --- | --- | --- | --- | --- | --- | --- | --- | --- | --- | --- | --- | --- | --- | --- | --- | --- | --- | --- | --- | --- | --- | --- | --- | --- | --- | --- |
| 24368070 | Procure Concrete for Shield House - Procurement |  | 62d | 2013-09-03 | 2013-11-27 | 24368065b FS-62d, 24368065a FS-62d, 24368065 FS-62d | 189d | 0d | 8/5 M-F w/JLAB Holidays ReBaseline | MECH TECH; PROCUREMENT<$50K 60 NO ESCALATION FY14; PROCUREMENT>$50K 69 NO ESCALATION FY14 | 213,025 | 24368360 | 2 | y | FENKER H | 1 | 1 | APP | D | HOWARD F | 08-052 | 09-022 | 10-069 | 11-025 | 11-046 | 12-012 | 12-036 | 12-054 | 13-006 | EJ | EJ | EJ | 13-015 | PR | OB |  |  |  |  |  |  |  |  |  |  |  |  |  |  |  |  |  |  |  |  |
| 24368070a | Procure Concrete for Shield House - Labor FY13 |  | 20d | 2013-09-03 | 2013-09-30 | 24368065 FS-62d, 24368065a FS-62d, 24368065b FS-62d | 189d | 0d | 8/5 M-F w/JLAB Holidays ReBaseline | MECH TECH [25.81 h] | 1,183.65 | 24368360 | 2 |  | FENKER H | 1 | 1 | APP | D | HOWARD F | 08-052 | 09-022 | 10-069 | 11-025 | 11-046 | 12-012 | 12-036 | 12-054 | 13-006 | EJ | EJ | EJ | 13-015 | PR |  |  |  |  |  |  |  |  |  |  |  |  |  |  |  |  |  |  |  |  |  |
| 24368120 | Long-lead procurements for AC Pwr for Support Structure |  | 20d | 2013-09-03 | 2013-09-30 | 24368070 FS-62d, 9-130M FS+228d, 24368070a FS-62d, 24368070b FS-62d | 355d | 104d | 8/5 M-F w/JLAB Holidays ReBaseline | PROCUREMENT<$50K 60 | 12,985 | 24368315 | 3 | y | FENKER H | 1 | 1 | APP | S | HOWARD F | 08-052 | 09-022 | 10-069 |  | 11-046 | 12-012 | 12-036 | 12-054 | 13-006 | EJ | EJ | EJ | 13-015 | PR | OB | 10-076 |  |  |  |  |  |  |  |  |  |  |  |  |  |  |  |  |  |  |  |
| 24368170 | Remove and Preserve C-Can and Lines |  | 20d | 2013-09-03 | 2013-09-30 | 9-130M FS+228d | 238d | 0d | 8/5 M-F w/JLAB Holidays ReBaseline | MECH DES [48 h]; MECH TECH [176 h] | 10,457.44 | 24368175 | 4 |  | FENKER H | 1 | 1 |  | H | HOWARD F |  | 09-022 | 10-069 | 11-025 | 11-046 | 12-012 | 12-036F | 12-054 | 13-006 |  | EJ |  | 13-015 | PR |  |  | NO RESOURCES | 11-026 |  |  |  |  |  |  |  |  |  |  |  |  |  |  |  |  |  |
| 24368190 | Complete Readiness Review for SHMS DCPS Testing FY13 |  | 20d | 2013-09-03 | 2013-09-30 | 9-130M FS+228d | 326d | 0d | 8/5 M-F w/JLAB Holidays ReBaseline | MECH ENG [12.12 h]; MECH DES [12.12 h]; SCIENTIST [12.12 h] | 2,362.55 | 24368207 | 5 |  | FENKER H | 1 | 1 |  | H | HOWARD F |  |  |  |  |  |  |  |  | 13-006 |  | PE |  | 13-015 | PR |  |  |  |  |  |  |  |  |  |  |  |  |  |  |  |  |  |  |  |  |  |
| 24368575LOE | Installation Management P1 |  | 20d | 2013-09-03 | 2013-09-30 | 9-130M FS+228d | 439d | 0d | 8/5 M-F w/JLAB Holidays ReBaseline | SCIENTIST [37.5 h]; MECH ENG [75 h] | 8,159.25 | 24368280LOE | 90 |  | FENKER H | 1 | 1 |  | E | HOWARD F |  |  | 10-069 |  | 11-046 |  |  |  | 13-006 |  | PE |  | 13-015 | PR |  |  |  | 11-026 |  |  |  |  |  |  |  |  |  |  |  |  |  |  |  |  |  |
| 24368015M | Cryogens Available from ESR or CHL | milestone | 0d | 2013-10-01 | 2013-10-01 | 9-140M | 309d | 0d | 8/5 M-F w/JLAB Holidays ReBaseline |  |  | 24368182M | 0 |  | FENKER H | 1 | 1 |  | M | HOWARD F |  | 09-022 | 10-069 |  | 11-046 | 12-012 | 12-036F |  | 13-006F |  |  |  | 13-015 | PR |  |  |  | 11-026 | Pat | 12-003 |  |  |  |  |  |  |  |  |  |  |  |  |  |  |  |
| 24368020 | Cool Down HMS Dipole |  | 5d | 2013-10-01 | 2013-10-07 | 24368015M | 309d | 0d | 8/5 M-F w/JLAB Holidays ReBaseline |  |  | 24368185 | 0 |  | FENKER H | 1 | 1 |  | Z | HOWARD F |  | 09-022 | 10-069 |  | 11-046 | 12-012 | 12-036F |  | 13-006F |  |  |  | 13-015 | PR |  |  | NO RESOURCES | 11-026 | Pat | 12-003 |  |  |  |  |  |  |  |  |  |  |  |  |  |  |  |
| 24368045 | Procure SHMS Steel Platforms and Stairs (Box O Parts) Part B |  | 87d | 2013-10-01 | 2014-02-13 | 9-140M | 255d | 0d | 8/5 M-F w/JLAB Holidays ReBaseline | PROCUREMENT>$50K 69 | 88,363.9 | 24368383 | 1 |  | FENKER H | 1 | 1 |  | D | HOWARD F | 08-052 | 09-022 | 10-069 |  | 11-046 | 12-012 | 12-036F |  | 13-006F | EJ |  |  | 13-015 | PR |  |  |  |  |  |  | 12-022 | 14-001 |  |  |  |  |  |  |  |  |  |  |  |  |  |
| 24368065b | Forming and Pouring Work for Concrete - Labor FY14 |  | 42d | 2013-10-01 | 2013-11-27 | 24368065a, 24368050 FS-20d, 9-130M FS+228d | 189d | 0d | 8/5 M-F w/JLAB Holidays ReBaseline | MECH DES [108.39 h]; MECH ENG [54.19 h] | 9,606.86 | 24368355 | 2 |  | FENKER H | 1 | 1 | APP | D | HOWARD F | 08-052 | 09-022 | 10-069 | 11-025 | 11-046 | 12-012 | 12-036 | 12-054 | 13-006 | EJ | EJ | EJ | 13-015 | PR |  |  |  |  |  |  |  | 14-001 | 08-016 | 09-012 |  |  |  |  |  |  |  |  |  |  |  |
| 24368070b | Procure Concrete for Shield House - Labor FY14 |  | 42d | 2013-10-01 | 2013-11-27 | 24368065 FS-62d, 24368065a FS-62d, 24368065b FS-62d, 24368070a | 189d | 0d | 8/5 M-F w/JLAB Holidays ReBaseline | MECH TECH [54.19 h] | 2,564.27 | 24368360 | 2 |  | FENKER H | 1 | 1 | APP | D | HOWARD F | 08-052 | 09-022 | 10-069 | 11-025 | 11-046 | 12-012 | 12-036 | 12-054 | 13-006 | EJ | EJ | EJ | 13-015 | PR |  |  |  |  |  |  |  | 14-001 |  |  |  |  |  |  |  |  |  |  |  |  |  |
| 24368190a | Complete Readiness Review for SHMS DCPS Testing FY14 |  | 13d | 2013-10-01 | 2013-10-17 | 24368190, 9-130M FS+228d | 326d | 5d | 8/5 M-F w/JLAB Holidays ReBaseline | MECH ENG [7.88 h]; MECH DES [7.88 h]; SCIENTIST [7.88 h] | 1,585.06 | 24368207 | 5 |  | FENKER H | 1 | 1 |  | H | HOWARD F |  |  |  |  |  |  |  |  | 13-006 |  | PE |  | 13-015 | PR |  |  |  |  |  |  |  | 14-001 |  |  |  |  |  |  |  |  |  |  |  |  |  |
| 24368580LOE | Installation Management P2 |  | 247d | 2013-10-01 | 2014-09-30 | 24368575LOE | 439d | 0d | 8/5 M-F w/JLAB Holidays ReBaseline | SCIENTIST [440 h]; MECH ENG [880 h] | 98,788.8 | 24368285LOE | 90 |  | FENKER H | 1 | 1 |  | E | HOWARD F |  |  | 10-069 |  | 11-046 |  |  |  | 13-006 |  | PE |  | 13-015 | PR |  |  |  | 11-026 |  |  |  | 14-001 |  |  |  |  |  |  |  |  |  |  |  |  |  |
| 24368025 | Cool Down HMS Q1 |  | 6d | 2013-10-08 | 2013-10-15 | 24368020 | 309d | 0d | 8/5 M-F w/JLAB Holidays ReBaseline |  |  | 24368190 | 0 |  | FENKER H | 1 | 1 |  | Z | HOWARD F |  | 09-022 | 10-069 |  | 11-046 | 12-012 | 12-036F |  | 13-006F |  |  |  | 13-015 | PR |  |  | NO RESOURCES | 11-026 | Pat | 12-003 |  |  |  |  |  |  |  |  |  |  |  |  |  |  |  |
| 24368195 | Prepare LCW for SHMS DCPS Testing |  | 6d | 2013-10-08 | 2013-10-15 | 24368190 FS-13d, 24368020, 24368190a FS-13d | 321d | 2d | 8/5 M-F w/JLAB Holidays ReBaseline | SUPPLIES & MATERIALS; MECH TECH [40 h] | 7,386.73 | 24368210 | 5 |  | FENKER H | 1 | 1 |  | H | HOWARD F |  | 09-022 | 10-069 |  | 11-046 | 12-012 | 12-036F |  | 13-006 |  | PE | PE | 13-015 | PR |  |  |  | 11-026 | Pat | 12-003 |  | 14-001 |  |  |  |  |  |  |  |  |  |  |  |  |  |
| 24368200 | Prepare AC Power for SHMS DCPS Testing |  | 6d | 2013-10-08 | 2013-10-15 | 24368020 | 321d | 2d | 8/5 M-F w/JLAB Holidays ReBaseline | ELEC ENG [80 h]; SUPPLIES & MATERIALS | 16,998.26 | 24368215 | 5 |  | FENKER H | 1 | 1 |  | S | HOWARD F |  | 09-022 | 10-069 |  | 11-046 | 12-012 | 12-036F |  | 13-006F |  | PE | PE | 13-015 | PR |  |  |  | 11-026 | Pat | 12-003 |  | 14-001 |  |  |  |  |  |  |  |  |  |  |  |  |  |
| 24368030 | Cool Down HMS Q2 |  | 10d | 2013-10-16 | 2013-10-29 | 24368025 | 309d | 0d | 8/5 M-F w/JLAB Holidays ReBaseline |  |  | 24368195 | 0 |  | FENKER H | 1 | 1 |  | Z | HOWARD F |  | 09-022 | 10-069 |  | 11-046 | 12-012 | 12-036F |  | 13-006F |  |  |  | 13-015 | PR |  |  | NO RESOURCES | 11-026 | Pat | 12-003 |  |  |  |  |  |  |  |  |  |  |  |  |  |  |  |
| 24368205 | Connect HMS Q1 to SHMS DCPS #1 |  | 2d | 2013-10-16 | 2013-10-17 | 24368025 | 319d | 0d | 8/5 M-F w/JLAB Holidays ReBaseline | ELEC TECH [32 h] | 1,503.68 | 24368220 | 5 |  | FENKER H | 1 | 1 |  | H | HOWARD F |  | 09-022 | 10-069 |  | 11-046 | 12-012 | 12-036F |  | 13-006F |  | PE |  | 13-015 | PR |  |  |  | 11-026 | Pat | 12-003 |  | 14-001 |  |  |  |  |  |  |  |  |  |  |  |  |  |
| 24368210 | Test Power Supply DCPS #1 |  | 3d | 2013-10-18 | 2013-10-22 | 24368195, 24368205, 24368200 | 319d | 0d | 8/5 M-F w/JLAB Holidays ReBaseline | MECH ENG [48 h] | 3,584.16 | 24368225 | 5 |  | FENKER H | 1 | 1 |  | H | HOWARD F |  | 09-022 | 10-069 |  | 11-046 | 12-012 | 12-036F |  | 13-006F |  | PE | PE | 13-015 | PR |  |  |  | 11-026 | Pat | 12-003 |  | 14-001 |  |  |  |  |  |  |  |  |  |  |  |  |  |
| 24368215 | Connect HMS Q1 to SHMS DCPS #2 |  | 2d | 2013-10-23 | 2013-10-24 | 24368210 | 319d | 0d | 8/5 M-F w/JLAB Holidays ReBaseline | ELEC TECH [32 h] | 1,503.68 | 24368230 | 5 |  | FENKER H | 1 | 1 |  | H | HOWARD F |  | 09-022 | 10-069 |  | 11-046 | 12-012 | 12-036F |  | 13-006F |  | PE | PE | 13-015 | PR |  |  |  | 11-026 | Pat | 12-003 |  | 14-001 |  |  |  |  |  |  |  |  |  |  |  |  |  |
| 24368220 | Test Power Supply DCPS #2 |  | 3d | 2013-10-25 | 2013-10-29 | 24368215 | 319d | 10d | 8/5 M-F w/JLAB Holidays ReBaseline | MECH ENG [48 h] | 3,584.16 | 24368235 | 5 |  | FENKER H | 1 | 1 |  | H | HOWARD F |  | 09-022 | 10-069 |  | 11-046 | 12-012 | 12-036F |  | 13-006F |  | PE |  | 13-015 | PR |  |  |  | 11-026 | Pat | 12-003 |  | 14-001 |  |  |  |  |  |  |  |  |  |  |  |  |  |
| 24368035 | Cool Down HMS Q3 |  | 10d | 2013-10-30 | 2013-11-12 | 24368030 | 309d | 0d | 8/5 M-F w/JLAB Holidays ReBaseline |  |  | 24368200 | 0 |  | FENKER H | 1 | 1 |  | Z | HOWARD F |  | 09-022 | 10-069 |  | 11-046 | 12-012 | 12-036F |  | 13-006F |  |  |  | 13-015 | PR |  |  | NO RESOURCES | 11-026 | Pat | 12-003 |  |  |  |  |  |  |  |  |  |  |  |  |  |  |  |
| 24368060 | Construct REAR Access Platform & Shield Wall |  | 75d | 2013-11-01 | 2014-02-28 | 9-140M FS+23d | 301d | 0d | 8/5 M-F w/JLAB Holidays ReBaseline | MECH DES [160 h]; MECH TECH [200 h]; MECH ENG [80 h]; PROCUREMENT<$50K 60 | 74,668.25 | 24368028 | 2 |  | FENKER H | 1 | 1 | APP | D | HOWARD F |  | 09-022 | 10-069 | 11-025 | 11-046 |  |  | 12-054 | 13-006 | PE | PE |  | 13-015 | PR |  |  |  | 11-026 |  |  |  | 14-001 |  |  |  |  |  |  |  |  |  |  |  |  |  |
| 24368075 | Re-Establish Hall-C Alignment Network After SHMS Assy |  | 5d | 2013-11-04 | 2013-11-08 | 24368070b FS-18d, 24368070 FS-18d, 24368070a FS-18d | 242d | 56d | 8/5 M-F w/JLAB Holidays ReBaseline | MECH TECH [80 h] | 3,785.6 | 24368362 | 2 |  | FENKER H | 1 | 1 | APP | H | HOWARD F |  |  |  |  |  |  |  |  | 13-006 | EJ | PE |  | 13-015 | PR |  |  |  |  |  |  |  | 14-001 |  |  |  |  |  |  |  |  |  |  |  |  |  |
| 24368080 | Concrete Hardening Period |  | 30d | 2013-11-04 | 2013-12-17 | 24368070a FS-18d, 24368070b FS-18d, 24368070 FS-18d | 189d | 0d | 8/5 M-F w/JLAB Holidays ReBaseline |  |  | 24368365 | 2 |  | FENKER H | 1 | 1 | APP | Z | HOWARD F | 08-052 | 09-022 | 10-069 | 11-025 | 11-046 | 12-012 | 12-036 | 12-054 | 13-006 |  | PE |  | 13-015 | PR |  |  | NO RESOURCES |  |  |  |  |  |  |  |  |  |  |  |  |  |  |  |  |  |  |
| 24368115 | Install LCW for Supprt Struct |  | 74d | 2013-11-04 | 2014-02-28 | 24368070 FS-18d, 24368070b FS-18d, 24368070a FS-18d | 257d | 6d | 8/5 M-F w/JLAB Holidays ReBaseline | ELEC TECH [160 h]; SUPPLIES & MATERIALS; PROCUREMENT>$50K 69; MECH TECH [400 h] | 56,536.09 | 24368317 | 3 |  | FENKER H | 1 | 1 | APP | S | HOWARD F | 08-052 | 09-022 | 10-069 |  | 11-046 | 12-012 | 12-036 | 12-054 | 13-006 | EJ | EJ | EJ | 13-015 | PR |  | 10-076 |  |  |  |  |  | 14-001 |  |  |  |  |  |  |  |  |  |  |  |  |  |
| 24368225 | Connect HMS Dipole to SHMS DCPS #3 |  | 2d | 2013-11-13 | 2013-11-14 | 24368220, 24368035 | 309d | 0d | 8/5 M-F w/JLAB Holidays ReBaseline | ELEC TECH [32 h] | 1,503.68 | 24368240 | 5 |  | FENKER H | 1 | 1 |  | H | HOWARD F |  | 09-022 | 10-069 |  | 11-046 | 12-012 | 12-036F | 12-054 | 13-006F |  | PE |  | 13-015 | PR |  |  |  | 11-026 | Pat | 12-003 |  | 14-001 |  |  |  |  |  |  |  |  |  |  |  |  |  |
| 24368230 | Test Power Supply DCPS #3 |  | 3d | 2013-11-15 | 2013-11-19 | 24368225 | 309d | 0d | 8/5 M-F w/JLAB Holidays ReBaseline | MECH ENG [48 h] | 3,584.16 | 24368245 | 5 |  | FENKER H | 1 | 1 |  | H | HOWARD F |  | 09-022 | 10-069 |  | 11-046 | 12-012 | 12-036F | 12-054 | 13-006F |  | PE |  | 13-015 | PR |  |  |  | 11-026 | Pat | 12-003 |  | 14-001 |  |  |  |  |  |  |  |  |  |  |  |  |  |
| 24368235 | Connect HMS Dipole to SHMS DCPS #4 |  | 2d | 2013-11-20 | 2013-11-21 | 24368230 | 309d | 0d | 8/5 M-F w/JLAB Holidays ReBaseline | ELEC TECH [32 h] | 1,503.68 | 24368250 | 5 |  | FENKER H | 1 | 1 |  | H | HOWARD F |  | 09-022 | 10-069 |  | 11-046 | 12-012 | 12-036F | 12-054 | 13-006F |  | PE |  | 13-015 | PR |  |  |  | 11-026 | Pat | 12-003 |  | 14-001 |  |  |  |  |  |  |  |  |  |  |  |  |  |
| 24368240 | Test Power Supply DCPS #4 |  | 3d | 2013-11-22 | 2013-11-26 | 24368235 | 309d | 0d | 8/5 M-F w/JLAB Holidays ReBaseline | MECH ENG [48 h] | 3,584.16 | 24368255 | 5 |  | FENKER H | 1 | 1 |  | H | HOWARD F |  | 09-022 | 10-069 |  | 11-046 | 12-012 | 12-036F | 12-054 | 13-006F |  | PE |  | 13-015 | PR |  |  |  | 11-026 | Pat | 12-003 |  | 14-001 |  |  |  |  |  |  |  |  |  |  |  |  |  |
| 24368245 | Connect HMS Dipole to SHMS DCPS #5 |  | 2d | 2013-11-27 | 2013-12-02 | 24368240 | 309d | 0d | 8/5 M-F w/JLAB Holidays ReBaseline | ELEC TECH [32 h] | 1,503.68 | 24368260 | 5 |  | FENKER H | 1 | 1 |  | H | HOWARD F |  | 09-022 | 10-069 |  | 11-046 | 12-012 | 12-036F | 12-054 | 13-006F |  | PE |  | 13-015 | PR |  |  |  | 11-026 | Pat | 12-003 |  | 14-001 |  |  |  |  |  |  |  |  |  |  |  |  |  |
| 24368175 | Install Cryo Boom Support |  | 27d | 2013-12-02 | 2014-01-17 | 24368170 FS+42d | 281d | 43d | 8/5 M-F w/JLAB Holidays ReBaseline | MECH DES [80 h]; MECH TECH [160 h]; PROCUREMENT<$50K 60 | 27,153.7 | 24368333 | 4 |  | FENKER H | 1 | 1 | APP | S | HOWARD F | 08-052 | 09-022 | 10-069 |  | 11-046 | 12-012 | 12-036F | 12-054 | 13-006 | EJ | EJ |  | 13-015 | PR |  |  | NO RESOURCES |  |  |  | 12-022 | 14-001 | 08-016 | 09-012 |  |  |  |  |  |  |  |  |  |  |  |
| 24368180 | Pre-Alignment SHMS Cryo Supports |  | 3d | 2013-12-02 | 2013-12-04 | 24368065b, 24368065, 24368065a | 305d | 67d | 8/5 M-F w/JLAB Holidays ReBaseline | MECH TECH [24 h] | 1,135.68 | 24368095 | 4 |  | FENKER H | 1 | 1 |  | H | HOWARD F |  | 09-022 | 10-069 |  | 11-046 | 12-012 | 12-036 | 12-054 | 13-006 |  | EJ |  | 13-015 | PR |  |  |  | 11-026 |  |  | 12-022 | 14-001 |  |  |  |  |  |  |  |  |  |  |  |  |  |
| 24368250 | Test Power Supply DCPS #5 |  | 3d | 2013-12-03 | 2013-12-05 | 24368245 | 309d | 58d | 8/5 M-F w/JLAB Holidays ReBaseline | MECH ENG [48 h] | 3,584.16 | 24368265 | 5 |  | FENKER H | 1 | 1 |  | H | HOWARD F |  | 09-022 | 10-069 |  | 11-046 | 12-012 | 12-036F | 12-054 | 13-006F |  | PE |  | 13-015 | PR |  |  |  | 11-026 | Pat | 12-003 |  | 14-001 |  |  |  |  |  |  |  |  |  |  |  |  |  |
| 24368455 | Install QR Magnets |  | 19d | 2013-12-17 | 2014-01-23 | 9-140M FS+53d | 479d |  | 8/5 M-F w/JLAB Holidays ReBaseline | MECH DES [80 h]; MECH TECH [160 h] | 11,675.2 | 24368425 | 8 |  | FENKER H | 1 | 1 |  | S | HOWARD F |  |  | 10-069 |  | 11-046 | 12-012 |  |  |  |  | EJ |  | 13-015 | PR |  |  |  |  |  |  |  | 14-001 |  |  | NB |  |  |  |  |  |  |  |  |  |  |
| 24368495 | Adjust Compton Elevation (Notebook) |  | 19d | 2013-12-17 | 2014-01-23 | 24368485 FS-162d | 474d | 0d | 8/5 M-F w/JLAB Holidays ReBaseline | MSHOP; MECH DES [80 h]; MECH TECH [360 h] | 26,298.7 | 24368420 | 8 |  | FENKER H | 1 | 1 |  | S | HOWARD F |  |  | 10-069 |  | 11-046 | 12-012 |  | 12-054 | 13-006 |  | EJ | EJ | 13-015 | PR |  |  |  |  |  |  |  | 14-001 |  |  | NB |  |  |  |  |  |  |  |  |  |  |
| 24368085M | Shield House Concrete Work Complete | milestone | 0d | 2013-12-17 | 2013-12-17 | 24368070a, 24368080, 24368070b, 24368070 | 189d | 3d | 8/5 M-F w/JLAB Holidays ReBaseline |  |  | 24368085M | 2 |  | FENKER H | 1 | 1 |  | M | HOWARD F |  | 09-022 | 10-069 | 11-025 | 11-046 | 12-012 | 12-036 | 12-054 | 13-006 |  |  |  | 13-015 | PR |  |  |  | 11-026 |  |  |  |  |  |  |  | 6 |  |  |  |  |  |  |  |  |  |
| 24368090 | Install Boron & Lead Shielding |  | 23d | 2014-01-02 | 2014-02-04 | 24368085M, 24363030aa | 186d | 0d | 8/5 M-F w/JLAB Holidays ReBaseline | PROCUREMENT<$50K 60; MECH TECH [560 h]; MECH DES [40 h]; MSHOP; SUPPLIES & MATERIALS | 78,242.27 | 24368080a | 2 |  | FENKER H | 1 | 1 | APP | S | HOWARD F | 08-052 | 09-022 | 10-069 | 11-025 | 11-046 |  | 12-036 | 12-054 | 13-006 | EJ | EJ | EJ | 13-015 | PR |  |  |  |  |  |  |  | 14-001 |  |  |  |  | 4362B | 10-025 |  |  |  |  |  |  |  |
| 24368125 | Install Cable Trays of Supprt Struct |  | 22d | 2014-01-02 | 2014-02-03 | 9-140M FS+57d, 24368085M | 276d | 25d | 8/5 M-F w/JLAB Holidays ReBaseline | PROCUREMENT>$50K 69; MECH DES [80 h]; MECH TECH [160 h] | 27,871.16 | 24368310 | 3 |  | FENKER H | 1 | 1 | APP | S | HOWARD F | 08-052 | 09-022 | 10-069 |  | 11-046 | 12-012 | 12-036 | 12-054 | 13-006 | EJ | EJ | PE | 13-015 | PR |  | 10-076 |  |  |  |  |  | 14-001 |  | 09-012 |  |  |  |  |  |  |  |  |  |  |  |
| 24368500 | Install Beam Line upstream of Target (6GeV) |  | 1d | 2014-01-24 | 2014-01-24 | 24368495 | 536d | 498d | 8/5 M-F w/JLAB Holidays ReBaseline |  |  | 24368437 | 8 |  | FENKER H | 1 | 1 |  | Z | HOWARD F |  |  | 10-069 |  | 11-046 | 12-012 |  | 12-054 | 13-006 |  | PE |  | 13-015 | PR |  |  |  |  |  |  |  |  |  |  |  |  |  |  |  |  |  |  |  |  |  |
| 24368130 | Install Fire Protection & Detection Sys of Supprt Struct |  | 21d | 2014-02-03 | 2014-03-03 | 24368085M, 9-140M FS+78d | 256d | 5d | 8/5 M-F w/JLAB Holidays ReBaseline | PROCUREMENT>$50K 69; ELEC TECH [160 h]; PLANT ENG [80 h] | 37,172.61 | 24368320 | 3 |  | FENKER H | 1 | 1 | APP | S | HOWARD F | 08-052 | 09-022 | 10-069 |  | 11-046 | 12-012 | 12-036 | 12-054 | 13-006 | EJ | EJ | EJ | 13-015 | PR |  | 10-076 |  |  |  |  |  | 14-001 |  |  |  |  |  |  |  |  |  |  |  |  |  |
| 24368505 | Install, Align, Leak-check Upstream Beam-Pipes & Girders (6GEV) |  | 5d | 2014-02-03 | 2014-02-07 | 24368495, 24351020 | 468d |  | 8/5 M-F w/JLAB Holidays ReBaseline |  |  | 24368438 | 8 |  | FENKER H | 1 | 1 |  | Z | HOWARD F |  |  |  |  |  |  |  |  | 13-006 |  | PE |  | 13-015 | PR |  |  |  |  |  |  |  |  |  |  |  |  |  |  |  |  |  |  |  |  |  |
| 24368122 | Install AC Pwr for Supprt Struct |  | 25d | 2014-02-04 | 2014-03-10 | 9-140M FS+79d, 24368070a FS-18d, 24368070b FS-18d, 24368070 FS-18d | 251d | 0d | 8/5 M-F w/JLAB Holidays ReBaseline | ELEC ENG [240 h]; SUPPLIES & MATERIALS; PROCUREMENT>$50K 69 | 104,419.99 | 24368315 | 3 |  | FENKER H | 1 | 1 | APP | S | HOWARD F | 08-052 | 09-022 | 10-069 |  | 11-046 | 12-012 | 12-036 | 12-054 | 13-006 | EJ | EJ | EJ | 13-015 | PR |  | 10-076 |  |  |  |  |  | 14-001 |  |  |  |  |  |  |  |  |  |  |  |  |  |
| 24368095 | Install Doors in Shield House |  | 5d | 2014-02-05 | 2014-02-11 | 24363037, 24363036, 24368090, 24363035, 24363037a, 24363037b | 186d | 0d | 8/5 M-F w/JLAB Holidays ReBaseline | MECH DES [80 h]; MECH TECH [160 h] | 11,675.2 | 24368087 | 2 |  | FENKER H | 1 | 1 |  | S | HOWARD F |  | 09-022 | 10-069 | 11-025 | 11-046 |  | 12-036 | 12-054 | 13-006 |  | EJ |  | 13-015 | PR |  |  |  |  |  |  |  | 14-001 |  |  |  |  |  |  |  |  |  |  |  |  |  |
| 24368140 | Install Cable Tray & Conduits (SHIELD HOUSE) |  | 25d | 2014-02-05 | 2014-03-11 | 24368090, 24363036, 24363035, 24363037, 24363037a, 24363037b | 196d | 0d | 8/5 M-F w/JLAB Holidays ReBaseline | PROCUREMENT<$50K 60; MECH TECH [160 h]; MECH DES [80 h] | 27,871.16 | 24368340 | 3 |  | FENKER H | 1 | 1 | APP | S | HOWARD F | 08-052 | 09-022 | 10-069 | 11-025 | 11-046 |  | 12-036 | 12-054 | 13-006 | EJ | EJ |  | 13-015 | PR |  |  |  |  |  |  |  | 14-001 |  |  |  |  | 4362B |  |  |  |  |  |  |  |  |
| 24368055 | Install SHMS Steel Platforms and Stairs |  | 15d | 2014-02-12 | 2014-03-04 | 24368040 FS-2d, 24368070b, 24368045 FS-2d, 24368070a, 24368070 | 255d | 0d | 8/5 M-F w/JLAB Holidays ReBaseline | PROCUREMENT<$50K 60; MECH TECH [240 h]; MECH DES [120 h] | 53,629.3 | 24368385 | 1 |  | FENKER H | 1 | 1 |  | D | HOWARD F | 08-052 | 09-022 | 10-069 |  | 11-046 | 12-012 | 12-036 | 12-054 | 13-006 | EJ | EJ | EJ | 13-015 | PR |  |  |  |  |  |  | 12-022 | 14-001 |  |  |  |  |  |  |  |  |  |  |  |  |  |
| 24368097 | Establish Alignment Network inside SHMS Shield House |  | 5d | 2014-02-12 | 2014-02-18 | 24368075, 24368095 | 186d | 0d | 8/5 M-F w/JLAB Holidays ReBaseline | MECH TECH [80 h] | 3,785.6 | 24368482 | 2 |  | FENKER H | 1 | 1 | APP | H | HOWARD F |  |  |  |  |  |  |  |  | 13-006 |  | PE |  | 13-015 | PR |  |  |  |  |  |  |  | 14-001 |  |  |  |  |  |  |  |  |  |  |  |  |  |
| 24368100 | Install and Align Detector Frames for DC and Rear Detectors |  | 5d | 2014-02-19 | 2014-02-25 | 24368075, 24368097, 24368095 | 186d | 0d | 8/5 M-F w/JLAB Holidays ReBaseline | MECH TECH [176 h]; MECH DES [40 h] | 10,380.32 | 24368362 | 2 |  | FENKER H | 1 | 1 | APP | S | HOWARD F |  |  |  |  |  |  |  |  | 13-006 |  | EJ | EJ | 13-015 | PR |  |  |  |  |  |  |  | 14-001 |  |  |  |  |  |  |  |  |  |  |  |  |  |
| 24368105 | Fab Raised Floor (SHIELD HOUSE) |  | 20d | 2014-02-26 | 2014-03-25 | 24368100, 24368097, 24368090 | 186d | 0d | 8/5 M-F w/JLAB Holidays ReBaseline | PROCUREMENT>$50K 69; PROCUREMENT<$50K 60; MECH DES [80 h] | 59,043.26 | 24368370 | 2 |  | FENKER H | 1 | 1 | APP | D | HOWARD F | 08-052 | 09-022 | 10-069 | 11-025 | 11-046 |  | 12-036 | 12-054 | 13-006 | EJ | EJ |  | 13-015 | PR |  |  |  |  |  |  |  | 14-001 |  |  |  |  |  |  |  |  |  |  |  |  |  |
| 24368475 | Beam-Dump Modifications & Upgrades (6GEV) |  | 30d | 2014-03-03 | 2014-04-11 | 24368060 | 423d |  | 8/5 M-F w/JLAB Holidays ReBaseline |  |  | 24368030 | 8 |  | FENKER H | 1 | 1 | APP | Z | HOWARD F |  | 09-022 | 10-069 | 11-025 | 11-046 |  |  | 12-054 | 13-006 |  | EJ |  | 13-015 | PR |  |  |  | 11-026 |  |  |  |  |  |  |  |  |  |  |  |  |  |  |  |  |  |
| 24368255 | Pre-Align Magnet Stand Locations |  | 2d | 2014-03-05 | 2014-03-06 | 24368055 | 293d | 0d | 8/5 M-F w/JLAB Holidays ReBaseline | MECH TECH [32 h] | 1,514.24 | 24368387 | 5 |  | FENKER H | 1 | 1 | APP | H | HOWARD F |  | 09-022 | 10-069 | 11-025 | 11-046 |  |  | 12-054 | 13-006 |  | PE |  | 13-015 | PR |  |  |  | 11-026 |  |  |  | 14-001 |  |  |  |  |  |  |  |  |  |  |  |  |  |
| 24368400 | Stack Calorimeter Blocks (SHOWER COUNTER) |  | 40d | 2014-03-05 | 2014-04-29 | 24368090, 24368060, 9-140M FS+100d, 24325030 | 299d | 0d | 8/5 M-F w/JLAB Holidays ReBaseline | MECH TECH [320 h] | 15,142.4 | 24368390 | 7 |  | FENKER H | 1 | 1 |  | U | HOWARD F |  | 09-022 | 10-069 |  | 11-046 |  | 12-036 | 12-054 | 13-006 |  | PE |  | 13-015 | PR |  |  |  |  |  |  |  | 14-001 |  | 09-012 |  |  |  |  | 07-024 |  |  |  |  |  |  |
| 24368260 | Pre-Align, Install and Assemble Lower Iron Yokes and HB, Q1 Stands |  | 5d | 2014-03-07 | 2014-03-13 | 24368255 | 293d |  | 8/5 M-F w/JLAB Holidays ReBaseline | MECH DES [120 h]; MECH ENG [40 h]; MECH TECH [320 h] | 24,285.2 | 24368473 | 5 |  | FENKER H | 1 | 1 |  | S | HOWARD F |  | 09-022 | 10-069 |  | 11-046 | 12-012 | 12-036 |  | 13-006 |  | PE |  | 13-015 | PR |  |  |  | 11-026 |  |  |  | 14-001 |  |  |  |  |  |  |  | 07-034 | 08-048 | 11-017 |  |  |  |
| 24368135 | Install Mag Pwr Supplies & Utilities on Platform |  | 30d | 2014-03-11 | 2014-04-21 | 24368115, 24368122, 24368125, 24368130, 24368120, 24368055, 24368250 | 252d | 7d | 8/5 M-F w/JLAB Holidays ReBaseline | MECH TECH [160 h]; ELEC TECH [160 h]; PROCUREMENT<$50K 60 | 24,084.59 | 24368105 | 3 |  | FENKER H | 1 | 1 | APP | S | HOWARD F |  | 09-022 | 10-069 | 11-025 | 11-046 | 12-012 | 12-036 | 12-054 | 13-006 | PE | PE |  | 13-015 | PR |  | 10-076 |  | 11-026 |  |  |  | 14-001 |  | 09-012 |  |  |  |  |  |  |  |  | IPL |  |  |
| 24368155 | Install Cables & Produce Final Drawings (CABLING) |  | 164d | 2014-03-12 | 2014-10-30 | 24368140, 24366025 FS-122d, 24368085M | 200d | 156d | 8/5 M-F w/JLAB Holidays ReBaseline | ELEC ENG [120 h]; SUPPLIES & MATERIALS; MECH ENG [120 h]; MECH TECH [1680 h]; MECH DES [160 h] | 111,723.94 | 24368470 | 3 |  | FENKER H | 1 | 1 |  | S | HOWARD F |  |  | 10-069 |  | 11-046 |  | 12-036 | 12-054 | 13-006 |  | PE | PE | 13-015 | PR |  |  |  |  |  |  |  | 14-001 |  |  |  |  |  |  |  |  |  |  |  |  |  |
| 24368265 | Connect Mag Pwr Supplies & instrument Controls |  | 55d | 2014-03-14 | 2014-05-30 | 24342055, 24315036a5 FS-13d, 24315037ba, 24368135 FS-34d, 24315037b | 246d | 0d | 8/5 M-F w/JLAB Holidays ReBaseline | MECH TECH [1000 h]; ELEC ENG [40 h]; PROCUREMENT<$50K 60; MECH ENG [520 h] | 94,809.72 | 24368110 | 5 |  | FENKER H | 1 | 1 | APP | S | HOWARD F |  | 09-022 | 10-069 |  | 11-046 | 12-012 | 12-036 | 12-054 | 13-006 | PE | PE |  | 13-015 | PR |  | 10-076 |  | 11-026 |  |  |  | 14-001 |  |  |  |  |  |  |  |  |  | 11-017 |  |  |  |
| 24368185 | Construct & Connect Cryogenic Lines |  | 80d | 2014-03-21 | 2014-07-14 | 24368180, 24364075, 24368175, 24364065, 24364043, 24368070, 24364043a, 24368070b, 24368070a, 24364016 | 238d | 0d | 8/5 M-F w/JLAB Holidays ReBaseline | MSHOP; MECH DES [200 h]; MECH TECH [2080 h]; MECH ENG [200 h] | 144,257.6 | 24368100 | 4 |  | FENKER H | 1 | 1 |  | S | HOWARD F |  | 09-022 | 10-069 |  | 11-046 | 12-012 | 12-036 | 12-054 | 13-006 |  | EJ | EJ | 13-015 | PR |  |  |  | 11-026 |  |  | 12-022 | 14-001 |  |  |  |  |  |  |  |  |  |  |  |  |  |
| 24368150 | Install Shield House Electrical Pwr (SHIELD HOUSE) |  | 80d | 2014-03-26 | 2014-07-17 | 24368105, 24368140 | 186d | 0d | 8/5 M-F w/JLAB Holidays ReBaseline | ELEC ENG [80 h]; PLANT ENG [40 h]; PROCUREMENT<$50K 60; MECH DES [80 h]; MECH ENG [80 h] | 56,228 | 24368375 | 3 |  | FENKER H | 1 | 1 |  | S | HOWARD F | 08-052 | 09-022 | 10-069 | 11-025 | 11-046 |  | 12-036 | 12-054 | 13-006 | EJ | EJ |  | 13-015 | PR |  |  |  |  |  |  |  | 14-001 |  |  |  |  |  |  |  |  |  |  |  |  |  |
| 24368270 | Prep for Review of Hot Check-out & Mag Control systems |  | 30d | 2014-04-18 | 2014-05-30 | 24368265 FS-30d | 246d | 0d | 8/5 M-F w/JLAB Holidays ReBaseline | MECH ENG [80 h]; ELEC ENG [120 h] | 14,989.2 | 24368130 | 5 |  | FENKER H | 1 | 1 |  | S | HOWARD F |  | 09-022 | 10-069 |  | 11-046 | 12-012 | 12-036 | 12-054 | 13-006 |  | PE |  | 13-015 | PR |  |  |  | 11-026 |  |  |  | 14-001 |  |  |  |  |  |  |  |  |  | 11-017 |  |  |  |
| 24368405 | Connect PMTs & Cables (SHOWER COUNTER) |  | 40d | 2014-04-30 | 2014-06-25 | 24325027a, 24368400 | 299d | 0d | 8/5 M-F w/JLAB Holidays ReBaseline | ELEC TECH [80 h] | 3,759.2 | 24368395 | 7 |  | FENKER H | 1 | 1 |  | H | HOWARD F |  | 09-022 | 10-069 |  | 11-046 |  | 12-036 | 12-054 | 13-006 |  | PE |  | 13-015 | PR |  |  |  |  |  |  |  | 14-001 |  | 09-012 |  |  |  |  | 07-024 |  |  |  |  |  |  |
| 24368460 | Install Moeller Quad #2 (6GEV) |  | 1d | 2014-05-14 | 2014-05-14 | 9-140M FS+150d | 474d | 0d | 8/5 M-F w/JLAB Holidays ReBaseline |  |  | 24368117 | 8 |  | FENKER H | 1 | 1 |  | Z | HOWARD F |  |  |  |  |  |  |  |  | 13-006 |  | PE | PE | 13-015 | PR |  |  |  |  |  |  |  |  |  |  |  |  |  |  |  |  |  |  |  |  |  |
| 24368275M | Comp safety Review of Hot Chkout procedures & Mag control systems | milestone | 0d | 2014-05-30 | 2014-05-30 | 24368270 | 246d | 0d | 8/5 M-F w/JLAB Holidays ReBaseline |  |  | 24368135M | 5 |  | FENKER H | 1 | 1 |  | Z | HOWARD F |  | 09-022 | 10-069 |  | 11-046 | 12-012 | 12-036 | 12-054 | 13-006 |  |  |  | 13-015 | PR |  |  |  | 11-026 |  |  |  |  |  |  |  | 6 |  |  |  |  |  | 11-017 |  |  |  |
| 24368280 | Perform Hot Check-out of Mag Pwr Supplies |  | 108d | 2014-06-02 | 2014-10-31 | 24368275M | 246d |  | 8/5 M-F w/JLAB Holidays ReBaseline | MECH ENG [160 h]; ELEC TECH [640 h]; ELEC ENG [160 h] | 54,041.6 | 24368140 | 5 |  | FENKER H | 1 | 1 |  | S | HOWARD F |  | 09-022 | 10-069 |  | 11-046 | 12-012 | 12-036 | 12-054 | 13-006 |  | PE |  | 13-015 | PR |  |  |  | 11-026 |  |  |  | 14-001 |  |  |  |  |  |  |  |  |  | 11-017 |  |  |  |
| 24368485 | Connect Additional Quad for Moeller polarimeter |  | 44d | 2014-06-13 | 2014-08-14 | 24368460 FS+20d, 24351030 | 474d | 0d | 8/5 M-F w/JLAB Holidays ReBaseline | ELEC TECH [80 h]; MECH TECH [200 h]; PROCUREMENT<$50K 60; ELEC ENG [40 h] | 17,776.25 | 24368415 | 8 |  | FENKER H | 1 | 1 |  | S | HOWARD F |  |  | 10-069 |  | 11-046 |  |  |  | 13-006 | EJ | PE |  | 13-015 | PR |  |  |  |  |  |  | 12-022 | 14-001 |  |  |  |  |  |  |  |  |  |  |  |  |  |
| 24368160 | Install Fire Protection and Flamm Gas det. (SHIELD HOUSE) |  | 20d | 2014-06-19 | 2014-07-17 | 24368165 FS-20d | 186d | 0d | 8/5 M-F w/JLAB Holidays ReBaseline | PROCUREMENT<$50K 60; ELEC TECH [200 h] | 48,995.34 | 24368380 | 3 |  | FENKER H | 1 | 1 | APP | S | HOWARD F | 08-052 | 09-022 | 10-069 | 11-025 | 11-046 |  | 12-036 | 12-054 | 13-006 | PE | PE |  | 13-015 | PR |  |  |  |  |  |  |  | 14-001 | 08-016 | 09-012 |  |  |  |  |  |  |  |  |  |  |  |
| 24368410 | Test Calorimeter (SHOWER COUNTER) |  | 37d | 2014-06-26 | 2014-08-18 | 24368405 | 299d | 273d | 8/5 M-F w/JLAB Holidays ReBaseline | VISTNG USERS [160 h] | 3,294.4 | 24368400 | 7 |  | FENKER H | 1 | 1 |  | S | HOWARD F |  | 09-022 | 10-069 |  | 11-046 |  | 12-036 | 12-054 | 13-006 |  | PE |  | 13-015 | PR |  |  |  |  |  |  |  | 14-001 |  | 09-012 |  |  |  |  | 07-024 |  |  |  | IPL |  |  |
| 24368285M | Receive First Mag from vendor | milestone | 0d | 2014-07-01 | 2014-07-01 | 2-27M | 217d |  | 8/5 M-F w/JLAB Holidays ReBaseline |  |  | 24368035M | 5 |  | FENKER H | 1 | 1 |  | M | HOWARD F |  | 09-022 | 10-069 |  | 11-046 | 12-012 | 12-036 |  | 13-006 |  |  |  | 13-015 | PR |  |  |  | 11-026 |  | 12-003 |  |  |  |  |  | 6 |  |  |  |  |  | 11-017 |  | 10-063 | 10-074 |
| 24368290 | Mount Q1 on Supprt Carriage |  | 5d | 2014-07-01 | 2014-07-08 | 24315036a5 FS-13d, 24315037ba FS+1d, 24312053M, 24315037b FS+1d | 273d | 4d | 8/5 M-F w/JLAB Holidays ReBaseline | MECH DES [24 h]; MSHOP; PROCUREMENT<$50K 60; MECH TECH [476 h] | 28,915.02 | 24368060 | 5 |  | FENKER H | 1 | 1 |  | S | HOWARD F |  | 09-022 | 10-069 |  | 11-046 | 12-012 | 12-036 | 12-054 | 13-006 | EJ | PE |  | 13-015 | PR |  |  |  | 11-026 |  |  |  | 14-001 |  |  |  |  |  |  |  |  |  | 11-017 |  |  | 10-074 |
| 24368165 | Install Shield House HVAC (SHIELD HOUSE) |  | 5d | 2014-07-11 | 2014-07-17 | 24368150 FS-5d | 186d | 0d | 8/5 M-F w/JLAB Holidays ReBaseline | ELEC TECH [16 h]; MECH TECH [240 h]; PROCUREMENT<$50K 60 | 33,075.82 | 24368345 | 3 |  | FENKER H | 1 | 1 |  | S | HOWARD F | 08-052 | 09-022 | 10-069 | 11-025 | 11-046 |  | 12-036 | 12-054 | 13-006 | PE | PE |  | 13-015 | PR |  |  |  |  |  |  |  | 14-001 |  |  |  |  |  |  |  |  |  |  |  |  |  |
| 24368415 | Install and Prep Electronics Room DAQ Racks (SHIELD HOUSE) |  | 20d | 2014-07-18 | 2014-08-14 | 24368160 | 186d | 0d | 8/5 M-F w/JLAB Holidays ReBaseline | ELEC TECH [80 h]; MECH TECH [160 h]; SUPPLIES & MATERIALS | 16,999.59 | 24368350 | 7 |  | FENKER H | 1 | 1 | APP | S | HOWARD F | 08-052 | 09-022 | 10-069 | 11-025 | 11-046 |  | 12-036 | 12-054 | 13-006 | EJ | PE | PE | 13-015 | PR |  |  |  |  |  |  |  | 14-001 | 08-016 | 09-012 |  |  |  |  |  |  |  |  |  |  |  |

Notes:
- 24368060: Entry Criteria: Ext Pred: COMPLETE MAGNET CONTRACT
- 24368455: Explanation: Budget contains 2 weeks of Survey & Alignment Tech in / the Mech Tech Budget. 12Aug2010 PMC
- 24368495: Explanation: Budget contains 4 weeks of Survey & Alignment / Tech in the Mech Tech Budget. 12Aug2010 PMC
- 24368095: Explanation: Removed 2.0 weeks of MT to keep CR11-046 a Level / 5
- 24368475: Entry Criteria: Ext Pred: COMPLETE MAGNET CONTRACT
- 24368255: Entry Criteria: Ext Pred: COMPLETE MAGNET CONTRACT
- 24368135: Explanation: IPL from 6 GeV 54342045
- 24368410: Explanation: IPL from 6 GeV 54341020
- 24368285M: Entry Criteria: Ext Pred: COMPLETE MAGNET CONTRACT

| ID | Activity | Type | Duration | Start | Finish | Predecessors | Total float | Free float | Calendar | Resources | Cost | Original Activity ID Rebaseline | Howard's Code | RESP - Responsibility | STRT%COMP for CM EVM | FNSH%COMP for CM EVM | EVMS Reporting Codes | CAM RESPONSIBLE | CR 10-069 | CR 11-025 | CR 11-026 | CR 11-046 | CR 12-036 | CR 12-054 | CR 13-006 | BOE Labor | CR 13-015 | Post Rebaseline | CR 14-001 | CR 07-024 | CR 09-012 | Advance Purchase Plan > 500K | CR 08-016 | CR 08-052 | CR 09-022 | BOE Procurement | CR 10-074 | CR 11-017 | CR 12-012 | Pat's Code | BOE Expenses | Milestone Level | CR 10-076 | CR 07-034 | CR 08-048 | 12 GEV MAJOR PROCUREMENT CATAGORY | CR 10-025 |
| --- | --- | --- | --- | --- | --- | --- | --- | --- | --- | --- | --- | --- | --- | --- | --- | --- | --- | --- | --- | --- | --- | --- | --- | --- | --- | --- | --- | --- | --- | --- | --- | --- | --- | --- | --- | --- | --- | --- | --- | --- | --- | --- | --- | --- | --- | --- | --- |
| 24368145 | Install Drift Gas Manifold |  | 30d | 2014-08-01 | 2014-09-12 | 24368140, 24324005, 24368090 | 281d | 255d | 8/5 M-F w/JLAB Holidays ReBaseline | MECH DES [80 h]; MECH TECH [80 h] | 7,889.6 | 24368093 | 3 | FENKER H | 1 | 1 | H | HOWARD F | 10-069 | 11-025 | 11-026 | 11-046 | 12-036 | 12-054 | 13-006 | PE | 13-015 | PR | 14-001 |  |  |  |  |  |  |  |  |  |  |  |  |  |  |  |  |  |  |
| 24368420 | Install Electrnc's (FAST Electrnc's) |  | 115d | 2014-08-15 | 2015-02-09 | 24325027a, 2433005 FS-75d, 2433000 FS-75d, 24341000, 24368415, 2433010 FS-75d, 24341000a, 24341085 | 186d | 160d | 8/5 M-F w/JLAB Holidays ReBaseline | ELEC TECH [800 h]; SCIENTIST [400 h] | 67,664 | 24368410 | 7 | FENKER H | 1 | 1 | S | HOWARD F | 10-069 |  |  | 11-046 | 12-036 | 12-054 | 13-006 | PE | 13-015 | PR | 14-001 | 07-024 | 09-012 |  |  |  |  |  |  |  |  |  |  |  |  |  |  |  |  |
| 24368570 | Install Rotation Controls of Supprt Struct |  | 20d | 2014-08-15 | 2014-09-12 | 24368415 | 316d |  | 8/5 M-F w/JLAB Holidays ReBaseline | MECH ENG [160 h]; PROCUREMENT>$50K 69; MECH TECH [360 h] | 129,850.63 | 24368305 | 11 | FENKER H | 1 | 1 | S | HOWARD F | 10-069 |  |  | 11-046 | 12-036 | 12-054 | 13-006 | PE | 13-015 | PR | 14-001 |  | 09-012 | APP | 08-016 | 08-052 | 09-022 | PE |  |  |  |  |  |  |  |  |  |  |  |
| 24368295 | Mount HB on Supprt Carriage |  | 5d | 2014-08-26 | 2014-09-02 | 28231005, 24368290 | 269d | 0d | 8/5 M-F w/JLAB Holidays ReBaseline | MECH DES [40 h]; MSHOP; PROCUREMENT<$50K 60; MECH TECH [40 h] | 9,104.3 | 24368055 | 5 | FENKER H | 1 | 1 | H | HOWARD F | 10-069 |  | 11-026 | 11-046 | 12-036 | 12-054 | 13-006 | PE | 13-015 | PR | 14-001 |  |  |  |  |  | 09-022 | EJ | 10-074 | 11-017 | 12-012 |  |  |  |  |  |  |  |  |
| 24368300 | Fiducialize Magnet CL of SHMS Q1 Magnet |  | 1d | 2014-08-26 | 2014-08-26 | 28231010 FS-5d | 293d |  | 8/5 M-F w/JLAB Holidays ReBaseline | MECH TECH [32 h]; MECH DES [8 h] | 1,924.64 | 24368266 | 5 | FENKER H | 1 | 1 | H | HOWARD F |  |  |  |  |  |  | 13-006 | PE | 13-015 | PR | 14-001 |  |  |  |  |  |  |  |  |  |  | Pat | PE |  |  |  |  |  |  |
| 24368550 | Prep Procurement of SHMS Angle Scribe Plates |  | 20d | 2014-10-01 | 2014-10-28 | 9-155M | 135d | 0d | 8/5 M-F w/JLAB Holidays ReBaseline | MECH DES [160 h] | 8,208 | 24368276 | 11 | FENKER H | 1 | 1 | H | HOWARD F |  |  |  |  |  |  | 13-006 | EJ | 13-015 | PR | 14-001 |  |  |  |  |  |  |  |  |  |  | Pat |  |  |  |  |  |  |  |
| 24368585LOE | Installation Management P3 |  | 247d | 2014-10-01 | 2015-10-01 | 24368580LOE | 439d | 0d | 8/5 M-F w/JLAB Holidays ReBaseline | SCIENTIST [440 h]; MECH ENG [880 h] | 98,788.8 | 24368290LOE | 90 | FENKER H | 1 | 1 | E | HOWARD F | 10-069 |  | 11-026 | 11-046 |  |  | 13-006 | PE | 13-015 | PR | 14-001 |  |  |  |  |  |  |  |  |  |  |  |  |  |  |  |  |  |  |
| 24368470 | Install Windows & Flanges |  | 30d | 2014-10-02 | 2014-11-12 | 24365035, 24311077, 24365040, 28231000 | 323d |  | 8/5 M-F w/JLAB Holidays ReBaseline | MECH ENG [80 h]; MECH DES [120 h]; MECH TECH [120 h] | 17,808 | 24368450 | 8 | FENKER H | 1 | 1 | S | HOWARD F | 10-069 |  |  | 11-046 | 12-036 | 12-054 | 13-006 | PE | 13-015 | PR | 14-001 |  | 09-012 |  | 08-016 |  | 09-022 |  |  |  | 12-012 |  | PE |  |  |  |  |  |  |
| 24368555 | Procure SHMS Angle Scribe Plates |  | 119d | 2014-10-29 | 2015-04-28 | 24368550 | 135d | 0d | 8/5 M-F w/JLAB Holidays ReBaseline | PROCUREMENT<$50K 60 | 41,276 | 24368277 | 11 | FENKER H | 1 | 1 | D | HOWARD F |  |  |  |  |  |  | 13-006 |  | 13-015 | PR | 14-001 |  |  |  |  |  |  | EJ |  |  |  | Pat |  |  |  |  |  |  |  |
| 24368510 | Install Target Scattering Chamber (6GEV) |  | 5d | 2015-01-08 | 2015-01-14 | 24354022, 24354030b, 9-140M FS+308d | 233d | 0d | 8/5 M-F w/JLAB Holidays ReBaseline |  |  | 24368012 | 9 | FENKER H | 1 | 1 | Z | HOWARD F |  |  |  |  |  |  | 13-006 |  | 13-015 | PR |  |  |  |  |  |  |  |  |  |  |  |  |  |  |  |  |  |  |  |
| 24368520 | Prep for Vac & pressure systems Safety Review |  | 10d | 2015-01-12 | 2015-01-26 | 9-140M FS+310d | 80d | 0d | 8/5 M-F w/JLAB Holidays ReBaseline | MECH ENG [80 h] | 5,973.6 | 24368115 | 10 | FENKER H | 1 | 1 | H | HOWARD F | 10-069 |  | 11-026 | 11-046 | 12-036F | 12-054 | 13-006F | PE | 13-015 | PR | 14-001 |  |  |  |  |  |  |  |  |  | 12-012 |  |  |  |  |  |  |  |  |
| 24368515 | Align Target Scattering Chamber (6GEV) |  | 5d | 2015-01-15 | 2015-01-22 | 24368510 | 233d |  | 8/5 M-F w/JLAB Holidays ReBaseline |  |  | 24368013 | 9 | FENKER H | 1 | 1 | Z | HOWARD F |  |  |  |  |  |  | 13-006 |  | 13-015 | PR |  |  |  |  |  |  |  |  |  |  |  |  |  |  |  |  |  |  |  |
| 24368525M | Comp safety Review of vacuum & pressure Vessel systems Implementn | milestone | 0d | 2015-01-26 | 2015-01-26 | 24368520 | 80d |  | 8/5 M-F w/JLAB Holidays ReBaseline |  |  | 24368120M | 10 | FENKER H | 1 | 1 | Z | HOWARD F | 10-069 |  | 11-026 | 11-046 | 12-036F | 12-054 | 13-006F |  | 13-015 | PR |  |  |  |  |  |  |  |  |  |  | 12-012 |  |  | 6 |  |  |  |  |  |
| 24368560 | Install & Align SHMS Angle Scribe Plates |  | 10d | 2015-04-29 | 2015-05-12 | 24368070, 24368070b, 24368555, 24368070a | 135d | 0d | 8/5 M-F w/JLAB Holidays ReBaseline | MECH TECH [240 h] | 11,356.8 | 24368278 | 11 | FENKER H | 1 | 1 | S | HOWARD F |  |  |  |  |  |  | 13-006 | PE | 13-015 | PR | 14-001 |  |  |  |  |  |  |  |  |  |  | Pat |  |  |  |  |  |  |  |
| 24368465 | Install Beam Stands (Beam Pipe) |  | 5d | 2015-05-04 | 2015-05-08 | 24368055, 24368085M, 24355025, 24355005, 24355010, 24355015 | 112d | 0d | 8/5 M-F w/JLAB Holidays ReBaseline | MECH ENG [120 h]; MECH DES [360 h] | 27,428.4 | 24368430 | 8 | FENKER H | 1 | 1 | S | HOWARD F | 10-069 |  |  | 11-046 |  | 12-054 |  | PE | 13-015 | PR | 14-001 |  | 09-012 |  | 08-016 |  |  |  |  |  | 12-012 |  | PE |  |  |  |  |  |  |
| 24368480 | Install Beam Pipe and Vac Fittings |  | 5d | 2015-05-11 | 2015-05-15 | 24355020, 24355030 FS-5d, 24368465 | 112d | 0d | 8/5 M-F w/JLAB Holidays ReBaseline | SUPPLIES & MATERIALS; MSHOP; MECH TECH [40 h] | 14,749.88 | 24368435 | 8 | FENKER H | 1 | 1 | S | HOWARD F | 10-069 |  |  | 11-046 |  | 12-054 |  | PE | 13-015 | PR | 14-001 |  |  |  |  |  |  |  |  |  | 12-012 |  | PE |  |  |  |  |  |  |
| 24368565 | Install SHMS Position Readback System |  | 20d | 2015-05-13 | 2015-06-11 | 24368560, 24368415 | 135d |  | 8/5 M-F w/JLAB Holidays ReBaseline | MECH TECH [120 h]; ELEC TECH [80 h]; SUPPLIES & MATERIALS; PROCUREMENT<$50K 60 | 20,890.44 | 24368300 | 11 | FENKER H | 1 | 1 | S | HOWARD F | 10-069 |  |  | 11-046 | 12-036 | 12-054 | 13-006 | PE | 13-015 | PR | 14-001 |  |  |  |  |  |  | EJ |  |  |  |  | PE |  |  |  |  |  |  |
| 24368490 | Leak Test Beam Pipe Vac Sys |  | 5d | 2015-05-18 | 2015-05-22 | 24368480 | 112d |  | 8/5 M-F w/JLAB Holidays ReBaseline | MECH TECH [160 h]; SUPPLIES & MATERIALS; MSHOP | 21,586.92 | 24368440 | 8 | FENKER H | 1 | 1 | S | HOWARD F | 10-069 |  |  | 11-046 |  | 12-054 | 13-006 | PE | 13-015 | PR | 14-001 |  |  |  |  |  |  |  |  |  | 12-012 |  | PE |  |  |  |  |  |  |
| 24368305 | Final Assemble & Mount Dipole on Supprt Carriage |  | 20d | 2015-05-19 | 2015-06-17 | 24368070b, 24368260, 24368070a, 24368097, 24368255, 24314050M, 24368070, 24368100, 24368285M | 0d |  | 8/5 M-F w/JLAB Holidays ReBaseline | MSHOP; PROCUREMENT>$50K 69; PROCUREMENT<$50K 60; MECH DES [80 h]; MECH ENG [40 h]; MECH TECH [1040 h] | 67,138.55 | 24368075 | 5 | FENKER H | 1 | 1 | S | HOWARD F | 10-069 |  | 11-026 | 11-046 | 12-036 |  | 13-006 | PE | 13-015 | PR | 14-001 |  |  | APP |  |  | 09-022 | EJ |  | 11-017 | 12-012 |  |  |  | 10-076 |  |  |  |  |
| 24368310 | Install & Connect Magnet Insulating Vac system |  | 30d | 2015-05-19 | 2015-07-01 | 24365020b, 24365025, 24365020, 24368525M, 24365020a, 24368305 FS-20d | 0d |  | 8/5 M-F w/JLAB Holidays ReBaseline | PROCUREMENT<$50K 60; MSHOP; MECH TECH [600 h] | 54,189.5 | 24368125 | 5 | FENKER H | 1 | 1 | S | HOWARD F | 10-069 |  | 11-026 | 11-046 | 12-036 |  | 13-006 | PE | 13-015 | PR | 14-001 |  |  |  |  |  | 09-022 | EJ |  | 11-017 | 12-012 |  | PE |  |  |  |  |  |  |
| 24368315 | Inspect & Assemble Upper Iron Yoke & Stands for Dipole magnet |  | 3d | 2015-06-18 | 2015-06-22 | 24368305 | 7d |  | 8/5 M-F w/JLAB Holidays ReBaseline | MECH TECH [160 h]; MECH ENG [8 h]; MECH DES [8 h] | 8,578.96 | 24368485 | 5 | FENKER H | 1 | 1 | H | HOWARD F | 10-069 |  | 11-026 | 11-046 | 12-036 |  | 13-006 | EJ | 13-015 | PR | 14-001 |  |  |  |  |  |  | EJ |  | 11-017 | 12-012 |  | EJ |  | 10-076 | 07-034 | 08-048 |  |  |
| 24368425 | Fiducialize SHMS Aerogel Cerenkov Counter (6GEV) |  | 1d | 2015-06-18 | 2015-06-18 | 24368305 | 48d | 4d | 8/5 M-F w/JLAB Holidays ReBaseline |  |  | 24368084 | 7 | FENKER H | 1 | 1 | Z | HOWARD F |  |  |  |  |  |  | 13-006 | EJ | 13-015 | PR |  |  |  | APP |  |  |  |  |  |  |  |  |  |  |  |  |  | 4362B | 10-025 |
| 24368430 | Fiducialize SHMS Drift Ch's, Hodoscopes, Cerenkovs, Preshower |  | 5d | 2015-06-18 | 2015-06-24 | 24368305 | 44d | 0d | 8/5 M-F w/JLAB Holidays ReBaseline | MECH TECH [160 h]; MECH DES [40 h] | 9,623.2 | 24368082 | 7 | FENKER H | 1 | 1 | H | HOWARD F |  |  |  |  |  |  | 13-006 | PE | 13-015 | PR | 14-001 |  |  | APP |  |  |  |  |  |  |  |  |  |  |  |  |  | 4362B |  |
| 24368435 | Install Detctr's in Shield House REAR |  | 65d | 2015-06-25 | 2015-09-25 | 24328010ba, 24368095, 24368155, 24368090, 24323005b, 24368400, 24368425, 24368430, 24363060 | 44d | 18d | 8/5 M-F w/JLAB Holidays ReBaseline | PROCUREMENT<$50K 60; ELEC TECH [400 h]; MECH TECH [480 h]; MSHOP | 90,399.9 | 24368120 | 7 | FENKER H | 1 | 1 | S | HOWARD F | 10-069 | 11-025 | 11-026 | 11-046 | 12-036 | 12-054 | 13-006 | PE | 13-015 | PR | 14-001 |  |  |  |  |  | 09-022 | EJ |  |  | 12-012 |  | PE |  |  |  |  |  |  |
| 24368325 | Assemble Upper Iron Yoke & Stands for Q2 magnet |  | 3d | 2015-07-16 | 2015-07-20 | 24368340 FS-27d, 24368350 FS-34d, 28236005 FS-34d | 2d |  | 8/5 M-F w/JLAB Holidays ReBaseline | MECH TECH [160 h]; MECH DES [8 h]; MECH ENG [8 h] | 8,578.96 | 24368480 | 5 | FENKER H | 1 | 1 | H | HOWARD F | 10-069 |  | 11-026 | 11-046 | 12-036 |  | 13-006 | EJ | 13-015 | PR | 14-001 |  |  |  |  |  | 09-022 |  |  | 11-017 | 12-012 |  |  |  |  | 07-034 | 08-048 |  |  |
| 24368340 | Mount Q2 on Supprt Carriage |  | 5d | 2015-07-16 | 2015-07-22 | 24314035a FS-34d, 24315037ba FS+1d, 24368350 FS-34d, 24314035 FS-34d, 2-30M, 28236005 FS-34d, 24315037b FS+1d | 0d |  | 8/5 M-F w/JLAB Holidays ReBaseline | PROCUREMENT<$50K 60; MECH TECH [720 h]; MSHOP | 39,229.9 | 24368065 | 5 | FENKER H | 1 | 1 | S | HOWARD F | 10-069 |  | 11-026 | 11-046 | 12-036 |  | 13-006 | PE | 13-015 | PR | 14-001 |  |  |  |  |  | 09-022 | EJ |  | 11-017 | 12-012 |  | EJ |  |  |  |  |  |  |
| 24368335M | First New SC Mag Cooled Down in place | milestone | 0d | 2015-08-07 | 2015-08-07 | 28236000, 24368185 | 61d |  | 8/5 M-F w/JLAB Holidays ReBaseline |  |  | 24368145M | 5 | FENKER H | 1 | 1 | M | HOWARD F | 10-069 |  | 11-026 | 11-046 | 12-036 | 12-054 | 13-006 |  | 13-015 | PR |  |  |  |  |  |  | 09-022 |  |  |  | 12-012 |  |  | 6 |  |  |  |  |  |
| 24368350 | Fiducialize Magnet CL of SHMS Dipole Magnet |  | 3d | 2015-08-26 | 2015-08-28 | 24314035a FS-5d | 2d |  | 8/5 M-F w/JLAB Holidays ReBaseline | MECH DES [24 h]; MECH TECH [96 h] | 5,773.92 | 24368022 | 5 | FENKER H | 1 | 1 | H | HOWARD F | 10-069 | 11-025 | 11-026 | 11-046 | 12-036F | 12-054 | 13-006 | PE | 13-015 | PR | 14-001 |  | 09-012 | APP | 08-016 |  | 09-022 |  |  |  | 12-012 |  | PE |  |  |  |  |  |  |
| 24368360 | Assemble Upper Iron Yoke & Stands for Q3 magnet |  | 3d | 2015-09-02 | 2015-09-04 | 28236005, 24314035a, 24368370 FS-7d, 24368350 | 3d |  | 8/5 M-F w/JLAB Holidays ReBaseline | MECH TECH [160 h]; MECH DES [8 h]; MECH ENG [8 h] | 8,578.96 | 24368475 | 5 | FENKER H | 1 | 1 | H | HOWARD F | 10-069 |  | 11-026 | 11-046 | 12-036 |  | 13-006 | EJ | 13-015 | PR | 14-001 |  |  |  |  |  | 09-022 | EJ |  | 11-017 | 12-012 |  |  |  |  | 07-034 | 08-048 |  |  |
| 24368365 | Finucialize Magnet CL of SHMS Q2 Magnet |  | 1d | 2015-09-02 | 2015-09-02 | 28236015 FS-1d | 42d |  | 8/5 M-F w/JLAB Holidays ReBaseline | MECH TECH [32 h]; MECH DES [8 h] | 1,924.64 | 24368492 | 5 | FENKER H | 1 | 1 | H | HOWARD F |  |  |  |  |  |  | 13-006 | EJ | 13-015 | PR | 14-001 |  |  |  |  |  |  |  |  |  |  |  |  |  |  |  |  | 4313 |  |
| 24368440 | Install Shutter Exit Window |  | 5d | 2015-09-02 | 2015-09-09 | 28236005 | 26d | 0d | 8/5 M-F w/JLAB Holidays ReBaseline | MECH ENG [80 h]; MECH DES [40 h]; MECH TECH [80 h]; ELEC TECH [80 h] | 15,570.4 | 24368455 | 7 | FENKER H | 1 | 1 | S | HOWARD F | 10-069 |  |  | 11-046 | 12-036 | 12-054 | 13-006 | EJ | 13-015 | PR | 14-001 |  | 09-012 |  | 08-016 |  | 09-022 |  |  |  | 12-012 |  | PE |  |  |  |  |  |  |
| 24368370 | Mount Q3 on Supprt Carriage |  | 5d | 2015-09-03 | 2015-09-10 | 28236010, 2-31M, 24315037ba FS+1d, 24315037b FS+1d, 24368340 | 0d |  | 8/5 M-F w/JLAB Holidays ReBaseline | PROCUREMENT<$50K 60; MSHOP; MECH TECH [720 h] | 39,229.9 | 24368070 | 5 | FENKER H | 1 | 1 | S | HOWARD F | 10-069 |  | 11-026 | 11-046 | 12-036 |  | 13-006 | PE | 13-015 | PR | 14-001 |  |  |  |  |  | 09-022 | EJ |  | 11-017 | 12-012 |  | EJ |  |  |  |  |  |  |
| 24368445 | Install Detctr's in Shield House FWD |  | 30d | 2015-09-10 | 2015-10-21 | 24363060, 24328010ba, 24368095, 24368440, 24368155, 24323012, 24323025, 24368090, 24368430, 24321015M, 24323005b | 26d | 0d | 8/5 M-F w/JLAB Holidays ReBaseline | PROCUREMENT<$50K 60; ELEC TECH [400 h]; MECH TECH [480 h]; MSHOP | 90,399.9 | 24368090 | 7 | FENKER H | 1 | 1 | S | HOWARD F | 10-069 | 11-025 | 11-026 | 11-046 | 12-036 | 12-054 | 13-006 | PE | 13-015 | PR | 14-001 |  |  |  |  |  | 09-022 | EJ |  |  | 12-012 |  | EJ |  |  |  |  |  |  |
| 24368450 | Hot Check-out of Detctr's in Shield House |  | 40d | 2015-09-28 | 2015-11-20 | 24368445 FS-18d, 24368410, 24368145, 24368435 FS-18d, 24368420 | 26d |  | 8/5 M-F w/JLAB Holidays ReBaseline | ELEC TECH [240 h] | 11,277.6 | 24368160 | 7 | FENKER H | 1 | 1 | S | HOWARD F | 10-069 | 11-025 | 11-026 | 11-046 | 12-036 | 12-054 | 13-006 | PE | 13-015 | PR | 14-001 |  |  |  |  |  | 09-022 |  |  |  | 12-012 |  |  |  |  |  |  |  |  |
| 24368590LOE | Installation Management P4 |  | 56d | 2015-10-02 | 2015-12-22 | 24368585LOE | 439d | 501d | 8/5 M-F w/JLAB Holidays ReBaseline | SCIENTIST [84 h]; MECH ENG [200 h] | 21,249.12 | 24368290LOE | 90 | FENKER H | 1 | 1 | E | HOWARD F | 10-069 |  | 11-026 | 11-046 |  |  | 13-006 | PE | 13-015 | PR | 14-001 |  |  |  |  |  |  |  |  |  |  |  |  |  |  |  |  |  |  |
| 24368110 | Install Roof Beams and Wall Blocks in Shield House |  | 1d | 2015-10-22 | 2015-10-22 | 24368435, 24368445 | 42d |  | 8/5 M-F w/JLAB Holidays ReBaseline | MECH TECH [16 h] | 757.12 | 24368090a | 2 | FENKER H | 1 | 1 | H | HOWARD F | 10-069 | 11-025 | 11-026 | 11-046 | 12-036 | 12-054 | 13-006 | EJ | 13-015 | PR | 14-001 |  |  |  |  |  | 09-022 | PE |  |  | 12-012 |  |  |  |  |  |  |  |  |
| 24368390 | Finucialize Magnet CL of SHMS Q3 Magnet |  | 1d | 2015-11-02 | 2015-11-02 | 28236025 FS-1d | 0d |  | 8/5 M-F w/JLAB Holidays ReBaseline | MECH DES [8 h]; MECH TECH [32 h] | 1,924.64 | 24368502 | 5 | FENKER H | 1 | 1 | H | HOWARD F | 10-069 |  | 11-026 | 11-046 | 12-036 |  | 13-006 | PE | 13-015 | PR | 14-001 |  |  |  |  |  | 09-022 |  |  | 11-017 | 12-012 |  |  |  |  | 07-034 | 08-048 |  |  |
| 24368530 | Install & Connect Spectrometer Vac system |  | 25d | 2015-11-03 | 2015-12-09 | 28236025, 24365050, 24365045, 24368525M, 24368490, 24354030, 24365047, 24368390, 28231000, 24354030b | 0d |  | 8/5 M-F w/JLAB Holidays ReBaseline | PROCUREMENT<$50K 60; MECH TECH [600 h]; MSHOP | 54,189.5 | 24368127 | 10 | FENKER H | 1 | 1 | S | HOWARD F | 10-069 |  | 11-026 | 11-046 | 12-036 | 12-054 | 13-006 | PE | 13-015 | PR | 14-001 |  |  |  |  |  | 09-022 | PE |  | 11-017 | 12-012 |  | PE |  |  |  |  |  |  |
| 24368535 | Install Spool & Bellows for All Magnets |  | 25d | 2015-11-03 | 2015-12-09 | 28231000, 28236025, 24368390, 24365032, 24365030 | 0d |  | 8/5 M-F w/JLAB Holidays ReBaseline | SUPPLIES & MATERIALS; MSHOP; MECH ENG [40 h]; MECH DES [40 h]; MECH TECH [160 h] | 32,406.43 | 24368445 | 10 | FENKER H | 1 | 1 | S | HOWARD F | 10-069 |  |  | 11-046 | 12-036 |  | 13-006 | PE | 13-015 | PR | 14-001 |  |  |  |  |  | 09-022 |  |  |  | 12-012 |  | PE |  |  |  |  |  |  |
| 24368540 | Install Slit Controls |  | 10d | 2015-12-10 | 2015-12-23 | 24368530, 24368440 FS-60d, 24365050, 24368470 FS-60d, 24368535 | 0d |  | 8/5 M-F w/JLAB Holidays ReBaseline | MECH TECH [176 h]; MECH ENG [40 h] | 11,315.12 | 24368465 | 10 | FENKER H | 1 | 1 | S | HOWARD F | 10-069 |  |  | 11-046 | 12-036 | 12-054 | 13-006 | PE | 13-015 | PR | 14-001 |  | 09-012 |  | 08-016 |  | 09-022 |  |  |  | 12-012 |  | PE |  |  |  |  |  |  |
| 24368545 | Install Sieve Slit Sys |  | 10d | 2015-12-10 | 2015-12-23 | 24368470 FS-60d, 24368535, 24365045, 24365047, 24368530 | 0d |  | 8/5 M-F w/JLAB Holidays ReBaseline | MSHOP; MECH ENG [80 h]; MECH TECH [176 h] | 55,120.04 | 24368460 | 10 | FENKER H | 1 | 1 | S | HOWARD F | 10-069 |  |  | 11-046 | 12-036 | 12-054 | 13-006 | PE | 13-015 | PR | 14-001 |  | 09-012 |  | 08-016 |  | 09-022 |  |  |  | 12-012 |  | PE |  |  |  |  |  |  |

Notes:
- 24368435: Caution: Danger !!! Need 25week duration for this task.
- 24368445: Caution: Danger !!! Need 25week duration for this task.

| ID | WBS | Activity | Duration | Start | Finish | Predecessors | Total float | Free float | Resources | Cost | RESP - Responsibility | STRT%COMP for CM EVM | FNSH%COMP for CM EVM | HALL D Related Milestones | CR 07-024 | CAM RESPONSIBLE | CR 09-012 | CR 11-004 | CR 11-006 | CR 11-036 | CR 11-053 | CR 12-054 | CR 08-058 | CR 09-027 | CR 09-027 Repair | CR 10-001 | 12 GeV 2nd level Critical Path | CR 09-014 | CR 08-055 | CR 10-024 | 12 GeV 3rd level Critical Path | CR 10-042 | CR 12-021 | CR 12-055 | Inter Project Link (IPL) | CIVIL CRITICAL MILESTONES | CR 10-061 | CR 08-016 |
| --- | --- | --- | --- | --- | --- | --- | --- | --- | --- | --- | --- | --- | --- | --- | --- | --- | --- | --- | --- | --- | --- | --- | --- | --- | --- | --- | --- | --- | --- | --- | --- | --- | --- | --- | --- | --- | --- | --- |
|  | 5 | **1.5 CONSTRUCTION HALL D** |  | 2008-10-01 | 2015-04-01 |  |  |  |  |  |  |  |  |  |  |  |  |  |  |  |  |  |  |  |  |  |  |  |  |  |  |  |  |  |  |  |  |  |
|  | 1 | **1.5.1 SOLENOID** |  | 2008-10-01 | 2013-09-30 |  |  |  |  |  |  |  |  |  |  |  |  |  |  |  |  |  |  |  |  |  |  |  |  |  |  |  |  |  |  |  |  |  |
| 151000 |  | Ship Iron to contractor (SOLENOID) | 10d | 2008-10-01 | 2008-10-14 | 9-090M | 925d | 0d |  |  | CHUDAKOV | 1 | 1 | D | 07-024 | EUGENE C | 09-012 | 11-004 | 11-006 | 11-036 | 11-053 | 12-054F |  |  |  |  |  |  |  |  |  |  |  |  |  |  |  |  |
| 151001 |  | Modify Iron Pole (SOLENOID) | 40d | 2008-10-15 | 2008-12-11 | 151000 | 925d | 0d |  |  | CHUDAKOV | 1 | 1 | D | 07-024 | EUGENE C | 09-012 | 11-004 | 11-006 | 11-036 | 11-053 | 12-054F |  |  |  |  |  |  |  |  |  |  |  |  |  |  |  |  |
| 151002 |  | Ship Iron to Jlab (SOLENOID) | 10d | 2008-12-12 | 2009-01-02 | 151001 | 925d | 684d |  |  | CHUDAKOV | 1 | 1 | D | 07-024 | EUGENE C | 09-012 | 11-004 | 11-006 | 11-036 | 11-053 | 12-054F |  |  |  |  |  |  |  |  |  |  |  |  |  |  |  |  |
| 151009E |  | FY09 Travel (SOLENOID) | 189d | 2009-01-02 | 2009-09-30 | 151009E5 | 431d | 0d | TRAVEL | 919.7 | CHUDAKOV | 1 | 1 | D | 07-024 | EUGENE C |  | 11-004 | 11-006 | 11-036 |  |  | 08-058 |  |  |  |  |  |  |  |  |  |  |  |  |  |  |  |
| 151000a |  | Labr/Exp to Proc/Assy/Test Rack for Coil Control + 1 Module (SOLENOIID) FY09 | 86d | 2009-06-01 | 2009-09-30 | 9-090M FS+162d | 383d | 0d | COMP SCIENT [196.57 h]; ELEC TECH [196.57 h]; ELEC ENG [73.71 h]; SUPPLIES & MATERIALS | 27,439.23 | CHUDAKOV | 1 | 1 | D | 07-024 | EUGENE C |  | 11-004 | 11-006 | 11-036 |  |  |  | 09-027 | 09-027 | 10-001B |  |  |  |  |  |  |  |  |  |  |  |  |
| 151000c |  | Design Test Platform (SOLENOID) | 66d | 2009-06-01 | 2009-09-01 | 9-090M FS+162d | 402d | 20d | MECH DES [320 h]; MECH ENG [120 h] | 21,686 | CHUDAKOV | 1 | 1 | D | 07-024 | EUGENE C |  | 11-004 | 11-006 | 11-036 |  |  |  | 09-027 | 09-027 |  | 2 | 09-014 |  |  |  |  |  |  |  |  |  |  |
| 151000e |  | Write Controls for Solenoid (SOLENOID) | 85d | 2009-06-01 | 2009-09-29 | 9-090M FS+162d | 383d | 1d | MECH ENG [320 h] | 20,419.2 | CHUDAKOV | 1 | 1 | D | 07-024 | EUGENE C |  | 11-004 | 11-006 | 11-036 |  |  |  | 09-027 | 09-027 |  | 2 | 09-014 |  |  |  |  |  |  |  |  |  |  |
| 151000d |  | Design Yoke Baffles (SOLENOID) | 64d | 2009-07-01 | 2009-09-30 | 9-090M FS+184d | 382d | 0d | MECH ENG [80 h]; MECH DES [320 h] | 19,133.6 | CHUDAKOV | 1 | 1 | D | 07-024 | EUGENE C |  | 11-004 | 11-006 | 11-036 |  |  |  | 09-027 | 09-027 |  | 2 | 09-014 |  |  |  |  |  |  |  |  |  |  |
| 151000b |  | Procure Rack for Coil Control + 1 Module Set for 1 Coil (SOLENOIID) | 60d | 2009-07-14 | 2009-10-06 | 151000aB FS-110d | 383d | 1d | PROCUREMENT<$50K 60 NO ESCALATION FY10 | 125,000 | CHUDAKOV | 1 | 1 | D | 07-024 | EUGENE C |  | 11-004 | 11-006 | 11-036 |  |  |  | 09-027 | 09-027 |  |  |  |  |  |  |  |  |  |  |  |  |  |
| 151000aB |  | Labr/Exp to Proc/Assy/Test Rack for Coil Control + 1 Module (SOLENOIID) FY10 | 54d | 2009-10-01 | 2009-12-17 | 151000a | 383d | 0d | ELEC ENG [46.29 h]; ELEC TECH [123.43 h]; SUPPLIES & MATERIALS; COMP SCIENT [123.43 h] | 17,779.66 | CHUDAKOV | 1 | 1 | D |  | EUGENE C |  | 11-004 | 11-006 | 11-036 |  |  |  |  |  | 10-001B |  |  |  |  |  |  |  |  |  |  |  |  |
| 151000f |  | Prepare Procurements/Fabrication Packages 2010 (SOLENOID) | 60d | 2009-10-01 | 2010-01-04 | 9-100M, 151000b FS-5d, 151000d, 151000e, 151000c | 382d | 0d | MECH ENG [200 h]; MECH DES [560 h] | 38,504.4 | CHUDAKOV | 1 | 1 | D | 07-024 | EUGENE C |  | 11-004 | 11-006 | 11-036 |  |  |  | 09-027 | 09-027 |  | 2 | 09-014 |  |  |  |  |  |  |  |  |  |  |
| 151010E |  | FY10 Travel (SOLENOID) | 248d | 2009-10-01 | 2010-09-30 | 151009E | 431d | 0d | TRAVEL | 1,244.93 | CHUDAKOV | 1 | 1 | D | 07-024 | EUGENE C |  | 11-004 | 11-006 | 11-036 |  |  |  |  |  |  |  |  |  |  |  |  |  |  |  |  |  |  |
| 151020 |  | Control Cabling fab (SOLENOID) | 60d | 2009-10-01 | 2010-01-04 | 9-100M | 517d | 0d | MECH ENG [20 h]; PROCUREMENT<$50K 60; MECH TECH [160 h]; MECH DES [20 h] | 12,196.55 | CHUDAKOV | 1 | 1 | D | 07-024 | EUGENE C |  | 11-004 | 11-006 | 11-036 | 11-053 | 12-054F |  |  |  |  |  |  |  |  |  |  |  |  |  |  |  |  |
| 151015 |  | Dsgn Ring Girders (SOLENOID) | 40d | 2010-01-05 | 2010-03-03 | 9-100M FS+60d | 637d | 396d | MECH ENG [120 h]; MECH DES [320 h] | 22,378.8 | CHUDAKOV | 1 | 1 | D | 07-024 | EUGENE C | 09-012 | 11-004 | 11-006 | 11-036 | 11-053 | 12-054F |  |  |  |  |  |  |  |  |  |  |  |  |  |  |  |  |
| 151023 |  | Design Iron Spacers (SOLENOID) | 40d | 2010-01-05 | 2010-03-03 | 151020 | 517d | 0d | MECH ENG [40 h]; MECH DES [160 h] | 9,872.4 | CHUDAKOV | 1 | 1 | D | 07-024 | EUGENE C |  | 11-004 | 11-006 | 11-036 | 11-053 | 12-054F |  |  |  |  |  |  |  |  |  |  |  |  |  |  |  |  |
| 151030 |  | Dsgn Missing Mounts (SOLENOID) | 20d | 2010-01-05 | 2010-02-02 | 9-100M FS+60d | 537d | 0d | MECH ENG [20 h]; MECH DES [120 h] | 6,745.8 | CHUDAKOV | 1 | 1 | D | 07-024 | EUGENE C | 09-012 | 11-004 | 11-006 | 11-036 | 11-053 | 12-054F |  |  |  |  |  |  |  |  |  |  |  |  |  |  |  |  |
| 151040 |  | Fab Stands (SOLENOID) | 80d | 2010-01-05 | 2010-04-28 | 9-100M FS+60d | 597d | 356d | MECH TECH [40 h]; PROCUREMENT<$50K 60; MECH ENG [40 h] | 20,612.03 | CHUDAKOV | 1 | 1 | D | 07-024 | EUGENE C | 09-012 | 11-004 | 11-006 | 11-036 | 11-053 | 12-054F |  |  |  |  |  |  | 08-055 |  |  |  |  |  |  |  |  |  |
| 151000g |  | Evaluate Procurements 2010 (SOLENOID) | 43d | 2010-02-02 | 2010-04-02 | 151000f FS+19d | 382d | 0d | MECH ENG [20 h] | 1,317 | CHUDAKOV | 1 | 1 | D | 07-024 | EUGENE C |  | 11-004 | 11-006 | 11-036 |  |  |  | 09-027 | 09-027 |  | 2 | 09-014 |  |  |  |  |  |  |  |  |  |  |
| 151033 |  | Fabricate Missing Mounts (SOLENOID) | 40d | 2010-02-03 | 2010-03-31 | 151030 | 537d | 0d | MECH ENG [40 h]; PROCUREMENT>$50K 69 | 11,424.28 | CHUDAKOV | 1 | 1 | D | 07-024 | EUGENE C |  | 11-004 | 11-006 | 11-036 | 11-053 | 12-054F |  |  |  |  |  |  |  |  |  |  |  |  |  |  |  |  |
| 151025 |  | Fab Iron Spacers (SOLENOID) | 120d | 2010-03-04 | 2010-08-20 | 151023, 9-100M FS+60d | 517d | 276d | MECH ENG [40 h]; PROCUREMENT>$50K 69; PROCUREMENT<$50K 60 | 124,599.16 | CHUDAKOV | 1 | 1 | D | 07-024 | EUGENE C |  | 11-004 | 11-006 | 11-036 | 11-053 | 12-054F |  |  |  |  |  |  |  |  |  |  |  |  |  |  |  |  |
| 151035 |  | Fab Ring Girders (SOLENOID) | 80d | 2010-04-01 | 2010-07-23 | 151033, 151000g FS-5d, 9-100M FS+60d | 537d | 296d | PROCUREMENT<$50K 60; MECH DES [40 h]; MECH ENG [20 h] | 47,078.01 | CHUDAKOV | 1 | 1 | D | 07-024 | EUGENE C | 09-012 | 11-004 | 11-006 | 11-036 | 11-053 | 12-054F |  |  |  |  |  |  |  |  |  |  |  |  |  |  |  |  |
| 151000h |  | Track Fabrication 2010 (SOLENOID) | 66d | 2010-05-03 | 2010-08-04 | 151000g FS+20d | 382d | 0d | MECH ENG [20 h] | 1,317 | CHUDAKOV | 1 | 1 | D | 07-024 | EUGENE C |  | 11-004 | 11-006 | 11-036 |  |  |  | 09-027 | 09-027 |  | 2 | 09-014 |  |  |  |  |  |  |  |  |  |  |
| 151000i |  | Acceptance Checks/Documentation 2010 (SOLENOID) | 64d | 2010-05-28 | 2010-08-27 | 151000h FS-47d | 382d | 73d | MECH ENG [40 h]; ELEC ENG [480 h] | 34,443.6 | CHUDAKOV | 1 | 1 | D | 07-024 | EUGENE C |  | 11-004 | 11-006 | 11-036 |  |  |  | 09-027 | 09-027 |  | 2 | 09-014 |  | 10-024 |  |  |  |  |  |  |  |  |
| 151011E |  | FY11 Travel (SOLENOID) | 248d | 2010-10-01 | 2011-09-30 | 151010E | 431d | 340d | TRAVEL | 1,285.77 | CHUDAKOV | 1 | 1 | D | 07-024 | EUGENE C |  | 11-004 | 11-006 | 11-036 |  |  |  |  |  |  |  |  |  |  |  |  |  |  |  |  |  |  |
| 151000j |  | Labor for Procurmnt Prep of 3 Module Sets for 3 Coils (SOLENOID) | 10d | 2010-12-14 | 2011-01-04 | 9-110M FS+50d, 151000i | 309d | 0d | MECH TECH [20 h] | 861.4 | CHUDAKOV | 1 | 1 | D | 07-024 | EUGENE C |  | 11-004 | 11-006 | 11-036 |  |  |  | 09-027 | 09-027 |  | 2 | 09-014 |  |  |  |  |  |  |  |  |  |  |
| 151171 |  | Prpare Procurement Packages for Cladding | 62d | 2011-01-04 | 2011-04-01 | 9-110M FS+59d | 208d | 148d | MECH DES [20 h]; MECH ENG [12 h] | 1,749 | CHUDAKOV | 1 | 1 | D | 07-024 | EUGENE C |  | 11-004 | 11-006 | 11-036 | 11-053 |  |  |  |  |  |  | 09-014 |  |  | 3 | 10-042 | 12-021F |  |  |  |  |  |
| 151000k |  | Procurmnt of 3 Module Sets for 3 Coils (SOLENOID) Part A | 65d | 2011-01-05 | 2011-04-07 | 151000j | 309d | 161d | PROCUREMENT>$50K 69; PROCUREMENT<$50K 60 | 120,584 | CHUDAKOV | 1 | 1 | D | 07-024 | EUGENE C |  | 11-004 | 11-006 | 11-036 |  |  |  | 09-027 | 09-027 |  | 2 | 09-014 |  |  |  |  |  | 12-055 |  |  |  |  |
| 151000ka |  | Procurmnt of 3 Module Sets for 3 Coils (SOLENOID) Part B | 65d | 2011-01-05 | 2011-04-07 | 151000j | 309d | 161d | PROCUREMENT>$50K 69 | 13,000 | CHUDAKOV | 1 | 1 | D | 07-024 | EUGENE C |  | 11-004 | 11-006 | 11-036 |  |  |  | 09-027 | 09-027 |  | 2 | 09-014 |  |  |  |  |  | 12-055 |  |  |  |  |
| 151045 |  | Set Up Solenoid Test Area (SOLENOID) (IPL 551400LOE) | 22d | 2011-08-30 | 2011-09-29 | 9-110M FS+225d, 2-16M, 2-10M FS+12d | 112d | 0d | MECH DES [320 h]; MECH ENG [240 h]; MECH TECH [480 h]; PROCUREMENT<$50K 60 | 57,588.92 | CHUDAKOV | 1 | 1 | D | 07-024 | EUGENE C | 09-012 | 11-004 | 11-006 | 11-036 | 11-053 | 12-054F |  |  |  |  |  |  |  |  | 3 | 10-042 |  |  | IPL | CVL | 10-061 |  |
| 151050 |  | Move Solenoid to H-D (SOLENOID) (IPL 551360) | 15d | 2011-10-03 | 2011-10-21 | 151030, 151015, 16331032, 151025, 3P-23M, 16331030, 151035, 151020, 151040, 151002, 151045 FS+1d | 241d | 129d | PROCUREMENT<$50K 60; MECH TECH [40 h]; MECH ENG [40 h] | 74,782.76 | CHUDAKOV | 1 | 1 | D | 07-024 | EUGENE C | 09-012 | 11-004 | 11-006 | 11-036 | 11-053 | 12-054F |  |  |  |  |  |  |  |  | 3 | 10-042 |  |  | IPL |  |  | 08-016 |
| 151060 |  | Install Solenoid Stands (SOLENOID) | 15d | 2011-10-03 | 2011-10-21 | 151045 FS+1d | 148d | 0d | MECH ENG [80 h]; PROCUREMENT>$50K 69; MECH TECH [400 h] | 28,065.62 | CHUDAKOV | 1 | 1 | D | 07-024 | EUGENE C |  | 11-004 | 11-006 | 11-036 |  |  |  |  |  |  |  |  |  |  | 3 | 10-042 |  |  |  |  |  |  |
| 151085 |  | Install Yoke mounts (SOLENOID) | 15d | 2011-10-03 | 2011-10-21 | 151045 FS+1d | 148d | 0d | MECH DES [12 h]; MECH ENG [40 h]; MECH TECH [200 h] | 12,270.84 | CHUDAKOV | 1 | 1 | D | 07-024 | EUGENE C |  | 11-004 | 11-006 | 11-036 |  |  |  |  |  |  |  |  |  |  | 3 | 10-042 |  |  |  |  |  |  |
| 151147 |  | Safety Review (SOLENOID) | 36d | 2011-10-03 | 2011-11-21 | 151045 FS+1d | 149d | 1d | MECH TECH [40 h]; PROCUREMENT>$50K 69; MECH ENG [480 h]; MECH DES [160 h] | 52,502.45 | CHUDAKOV | 1 | 1 | D | 07-024 | EUGENE C |  | 11-004 | 11-006 | 11-036 |  |  |  |  |  |  |  |  |  |  | 3 | 10-042 |  |  |  |  |  |  |
| 151160 |  | Install US Pole (SOLENOID) | 3d | 2011-10-12 | 2011-10-14 | 151060 FS-8d, 151085 FS-8d | 148d | 0d | MECH DES [12 h]; MECH ENG [16 h]; PROCUREMENT<$50K 60; MECH TECH [40 h] | 12,837.61 | CHUDAKOV | 1 | 1 | D | 07-024 | EUGENE C |  | 11-004 | 11-006 | 11-036 |  |  |  |  |  |  |  |  |  |  | 3 | 10-042 |  |  |  | CVL |  |  |
| 151090 |  | Install Yoke 1 (SOLENOID) | 5d | 2011-10-17 | 2011-10-21 | 151160 | 148d | 0d | MECH DES [12 h]; MECH TECH [16 h]; PROCUREMENT<$50K 60; MECH ENG [8 h] | 11,210.09 | CHUDAKOV | 1 | 1 | D | 07-024 | EUGENE C |  | 11-004 | 11-006 | 11-036 |  |  |  |  |  |  |  |  |  |  | 3 | 10-042 |  |  |  |  |  |  |
| 151095 |  | Install Coil 1 (SOLENOID) | 3d | 2011-10-24 | 2011-10-26 | 151090 | 148d | 0d | MECH ENG [8 h]; MECH TECH [16 h]; PROCUREMENT<$50K 60 | 10,632.05 | CHUDAKOV | 1 | 1 | D | 07-024 | EUGENE C |  | 11-004 | 11-006 | 11-036 |  |  |  |  |  |  |  |  |  |  | 3 | 10-042 |  |  |  |  |  |  |
| 151100 |  | Install Iron Spacer/Ring Girder 1 (SOLENOID) | 2d | 2011-10-27 | 2011-10-28 | 151095 | 148d | 0d | MECH TECH [32 h]; PROCUREMENT<$50K 60; MECH ENG [16 h] | 11,904.05 | CHUDAKOV | 1 | 1 | D | 07-024 | EUGENE C |  | 11-004 | 11-006 | 11-036 |  |  |  |  |  |  |  |  |  |  | 3 | 10-042 |  |  |  |  |  |  |
| 151105 |  | Install Yoke 2 (SOLENOID) | 2d | 2011-10-31 | 2011-11-01 | 151100 | 148d | 0d | MECH DES [12 h]; MECH ENG [8 h]; MECH TECH [16 h]; PROCUREMENT>$50K 69 | 11,210.09 | CHUDAKOV | 1 | 1 | D | 07-024 | EUGENE C |  | 11-004 | 11-006 | 11-036 |  |  |  |  |  |  |  |  |  |  | 3 | 10-042 |  |  |  |  |  |  |
| 151171a |  | Procure Cladding | 99d | 2011-11-01 | 2012-03-30 | 151171, 9-120M FS+21d | 60d | 0d | PROCUREMENT<$50K 60; PROCUREMENT>$50K 69 | 103,190 | CHUDAKOV | 1 | 1 | D | 07-024 | EUGENE C |  | 11-004 | 11-006 | 11-036 | 11-053 |  |  |  |  |  |  | 09-014 |  |  | 3 | 10-042 | 12-021F |  |  |  |  |  |
| 151110 |  | Install Coil 2 (SOLENOID) | 1d | 2011-11-02 | 2011-11-02 | 151105 | 148d | 0d | MECH TECH [16 h]; PROCUREMENT>$50K 69; MECH ENG [8 h] | 10,632.05 | CHUDAKOV | 1 | 1 | D | 07-024 | EUGENE C |  | 11-004 | 11-006 | 11-036 |  |  |  |  |  |  |  |  |  |  | 3 | 10-042 |  |  |  |  |  |  |
| 151115 |  | Install Iron Spacer/Ring Girder 2 (SOLENOID) | 2d | 2011-11-03 | 2011-11-04 | 151110 | 148d | 0d | MECH ENG [16 h]; MECH TECH [32 h]; PROCUREMENT>$50K 69 | 11,904.05 | CHUDAKOV | 1 | 1 | D | 07-024 | EUGENE C |  | 11-004 | 11-006 | 11-036 |  |  |  |  |  |  |  |  |  |  | 3 | 10-042 |  |  |  |  |  |  |
| 151120 |  | Install Yoke 3 (SOLENOID) | 2d | 2011-11-07 | 2011-11-08 | 151115 | 148d | 0d | PROCUREMENT>$50K 69; MECH ENG [8 h]; MECH TECH [16 h]; MECH DES [12 h] | 11,210.09 | CHUDAKOV | 1 | 1 | D | 07-024 | EUGENE C |  | 11-004 | 11-006 | 11-036 |  |  |  |  |  |  |  |  |  |  | 3 | 10-042 |  |  |  |  |  |  |
| 151125 |  | Install Coil 3 (SOLENOID) | 1d | 2011-11-09 | 2011-11-09 | 151120 | 148d | 0d | PROCUREMENT>$50K 69; MECH ENG [8 h]; MECH TECH [16 h] | 10,632.05 | CHUDAKOV | 1 | 1 | D | 07-024 | EUGENE C |  | 11-004 | 11-006 | 11-036 |  |  |  |  |  |  |  |  |  |  | 3 | 10-042 |  |  |  |  |  |  |
| 151130 |  | Install Iron Spacer/Ring Girder 3 (SOLENOID) | 2d | 2011-11-10 | 2011-11-11 | 151125 | 148d | 0d | PROCUREMENT>$50K 69; MECH ENG [16 h]; MECH TECH [32 h] | 11,904.05 | CHUDAKOV | 1 | 1 | D | 07-024 | EUGENE C |  | 11-004 | 11-006 | 11-036 |  |  |  |  |  |  |  |  |  |  | 3 | 10-042 |  |  |  |  |  |  |
| 151135 |  | Install Yoke 4 (SOLENOID) | 2d | 2011-11-14 | 2011-11-15 | 151130 | 148d | 0d | MECH DES [12 h]; MECH ENG [8 h]; MECH TECH [16 h]; PROCUREMENT>$50K 69 | 11,210.09 | CHUDAKOV | 1 | 1 | D | 07-024 | EUGENE C |  | 11-004 | 11-006 | 11-036 |  |  |  |  |  |  |  |  |  |  | 3 | 10-042 |  |  |  |  |  |  |
| 151140 |  | Install Coil 4 (SOLENOID) | 3d | 2011-11-16 | 2011-11-18 | 151135 | 148d | 0d | MECH TECH [16 h]; PROCUREMENT>$50K 69; MECH ENG [8 h] | 10,632.05 | CHUDAKOV | 1 | 1 | D | 07-024 | EUGENE C |  | 11-004 | 11-006 | 11-036 |  |  |  |  |  |  |  |  |  |  | 3 | 10-042 |  |  |  |  |  |  |
| 151145 |  | Install Iron Spacer/Ring Girder 4 (SOLENOID) | 2d | 2011-11-21 | 2011-11-22 | 151140 | 148d | 0d | PROCUREMENT>$50K 69; MECH ENG [16 h]; MECH TECH [32 h] | 11,904.05 | CHUDAKOV | 1 | 1 | D | 07-024 | EUGENE C |  | 11-004 | 11-006 | 11-036 |  |  |  |  |  |  |  |  |  |  | 3 | 10-042 |  |  |  |  |  |  |
| 151170 |  | Install DS Pole (SOLENOID) (IPL) | 1d | 2011-11-23 | 2011-11-23 | 151147, 151145 | 148d | 0d | MECH TECH [40 h]; PROCUREMENT<$50K 60; MECH ENG [16 h]; MECH DES [12 h] | 12,837.61 | CHUDAKOV | 1 | 1 | D | 07-024 | EUGENE C |  | 11-004 | 11-006 | 11-036 |  |  |  |  |  |  |  | 09-014 |  |  | 3 | 10-042 |  |  |  |  |  |  |
| 151150 |  | Elect Test Coils (SOLENOID) | 5d | 2011-11-28 | 2011-12-02 | 151000ka, 151000k, 151170, 151147 | 148d | 0d | PROCUREMENT<$50K 60; MECH ENG [8 h]; MECH TECH [120 h] | 7,063.77 | CHUDAKOV | 1 | 1 | D | 07-024 | EUGENE C | 09-012 | 11-004 | 11-006 | 11-036 |  |  |  |  |  |  |  |  |  |  | 3 | 10-042 |  |  |  |  |  |  |
| 151155 |  | Leak Test Coils (SOLENOID) | 10d | 2011-12-05 | 2011-12-16 | 151150 | 148d | 140d | MECH TECH [200 h]; MECH ENG [8 h]; PROCUREMENT<$50K 60 | 10,618.97 | CHUDAKOV | 1 | 1 | D | 07-024 | EUGENE C |  | 11-004 | 11-006 | 11-036 |  |  |  |  |  |  |  |  |  |  | 3 | 10-042 |  |  |  | CVL |  |  |
| 151055 |  | Install DC Sys (SOLENOID) | 34d | 2012-01-13 | 2012-03-02 | 151045 FS+67d | 112d | 0d | MECH ENG [40 h]; MECH TECH [320 h]; PROCUREMENT>$50K 69 | 22,875.64 | CHUDAKOV | 1 | 1 | D | 07-024 | EUGENE C | 09-012 | 11-004 | 11-006 | 11-036 | 11-053 | 12-054F |  |  |  |  |  |  |  |  | 3 | 10-042 |  |  |  |  |  |  |
| 151065 |  | Install Solenoid Controls (SOLENOID) (IPL) | 34d | 2012-01-13 | 2012-03-02 | 151045 FS+67d | 112d | 0d | PROCUREMENT<$50K 60; MECH ENG [80 h]; MECH TECH [320 h] | 23,340.41 | CHUDAKOV | 1 | 1 | D | 07-024 | EUGENE C | 09-012 | 11-004 | 11-006 | 11-036 | 11-053 | 12-054F |  |  |  |  |  |  |  |  | 3 | 10-042 |  |  |  |  |  |  |
| 151173 |  | Develop cryo/magnet elect/pipe interface | 44d | 2012-02-03 | 2012-04-05 | 9-120M FS+80d | 190d | 0d | MECH DES [170 h]; MECH ENG [170 h] | 20,109.3 | CHUDAKOV | 1 | 1 | D |  | EUGENE C |  |  |  |  |  |  |  |  |  |  |  |  |  |  | 3 |  | 12-021 |  |  |  |  |  |
| 151173a |  | Procure elec/piping interface hardware Part A | 103d | 2012-02-03 | 2012-06-29 | 151173 FS-44d | 190d | 64d | PROCUREMENT<$50K 60; PROCUREMENT>$50K 69 | 52,000 | CHUDAKOV | 1 | 1 | D |  | EUGENE C |  |  |  |  |  |  |  |  |  |  |  |  |  |  | 3 |  | 12-021 | 12-055 |  |  |  |  |
| 151173aa |  | Procure elec/piping interface hardware Part B | 103d | 2012-02-03 | 2012-06-29 | 151173 FS-44d | 190d | 64d | PROCUREMENT>$50K 69 | 43,000 | CHUDAKOV | 1 | 1 | D |  | EUGENE C |  |  |  |  |  |  |  |  |  |  |  |  |  |  | 3 |  | 12-021 | 12-055 |  |  |  |  |
| 151173j |  | Develop shims and baffle support | 56d | 2012-02-03 | 2012-04-23 | 9-120M FS+80d | 277d | 0d | MECH DES [34.08 h]; MECH ENG [51.12 h] | 5,226.16 | CHUDAKOV | 1 | 1 | D |  | EUGENE C |  |  |  |  |  |  |  |  |  |  |  |  |  |  | 3 |  | 12-021 |  |  |  |  |  |
| 151173c |  | Develop solenoid vacuum manifold | 63d | 2012-02-06 | 2012-05-03 | 9-120M FS+81d | 217d | 0d | MECH ENG [102 h]; MECH DES [170 h] | 15,341.14 | CHUDAKOV | 1 | 1 | D |  | EUGENE C |  |  |  |  |  |  |  |  |  |  |  |  |  |  | 3 |  | 12-021 |  |  |  |  |  |
| 151173g |  | FMEA for solenoid | 12d | 2012-02-06 | 2012-02-22 | 9-120M FS+81d | 338d | 247d | MECH ENG [340 h] | 23,840.8 | CHUDAKOV | 1 | 1 | D |  | EUGENE C |  |  |  |  |  |  |  |  |  |  |  |  |  |  | 3 |  | 12-021 |  |  |  |  |  |
| 151173d |  | Procure solenoid vacuum manifold Part A | 83d | 2012-03-05 | 2012-06-29 | 151173c FS-44d | 217d | 0d | PROCUREMENT<$50K 60 | 27,000 | CHUDAKOV | 1 | 1 | D |  | EUGENE C |  |  |  |  |  |  |  |  |  |  |  |  |  |  | 3 |  | 12-021 | 12-055 |  |  |  |  |
| 151173d5 |  | Procure solenoid vacuum manifold Part B | 83d | 2012-03-05 | 2012-06-29 | 151173c FS-44d | 217d | 0d | PROCUREMENT<$50K 60 | 8,000 | CHUDAKOV | 1 | 1 | D |  | EUGENE C |  |  |  |  |  |  |  |  |  |  |  |  |  |  | 3 |  | 12-021 | 12-055 |  |  |  |  |
| 151173k |  | Procure shims and baffle support | 62d | 2012-03-06 | 2012-05-31 | 151173j FS-35d | 277d | 0d | PROCUREMENT<$50K 60 | 12,000 | CHUDAKOV | 1 | 1 | D |  | EUGENE C |  |  |  |  |  |  |  |  |  |  |  |  |  |  | 3 |  | 12-021 |  |  |  |  |  |
| 151172 |  | Install Cladding (SOLENOID) | 24d | 2012-04-10 | 2012-05-11 | 151171a FS+6d, 151170 | 60d | 52d | SUPPLIES & MATERIALS; MECH DES [2 h]; MECH ENG [2 h]; MECH TECH [480 h] | 24,567.78 | CHUDAKOV | 1 | 1 | D | 07-024 | EUGENE C |  | 11-004 | 11-006 | 11-036 | 11-053 |  |  |  |  |  |  | 09-014 |  |  | 3 | 10-042 | 12-021 |  |  |  |  |  |
| 151173n |  | Install shims and baffle support | 46d | 2012-04-19 | 2012-06-25 | 151173k FS-30d | 277d | 257d | MECH TECH [272 h] | 12,087.68 | CHUDAKOV | 1 | 1 | D |  | EUGENE C |  |  |  |  |  |  |  |  |  |  |  |  |  |  | 3 |  | 12-021 |  |  |  |  |  |
| 151070 |  | Install DC Buswork (SOLENOID) | 20d | 2012-05-04 | 2012-06-01 | 151055 FS+44d, 151050, 151065 FS+44d | 112d | 0d | PROCUREMENT>$50K 69; MECH TECH [320 h]; MECH ENG [40 h]; MECH DES [40 h] | 42,352.51 | CHUDAKOV | 1 | 1 | D | 07-024 | EUGENE C |  | 11-004 | 11-006 | 11-036 | 11-053 | 12-054F |  |  |  |  |  |  |  |  | 3 | 10-042 |  |  |  |  |  |  |
| 151075 |  | Test DC Sys (SOLENOID) | 20d | 2012-05-04 | 2012-06-01 | 151070 FS-20d | 112d | 0d | MECH ENG [40 h]; MECH DES [200 h] | 12,438.8 | CHUDAKOV | 1 | 1 | D | 07-024 | EUGENE C |  | 11-004 | 11-006 | 11-036 | 11-053 | 12-054F |  |  |  |  |  |  |  |  | 3 | 10-042 |  |  |  |  |  |  |
| 151080 |  | Install Controls Cabling (SOLENOID) | 20d | 2012-05-04 | 2012-06-01 | 151075 FS-20d | 112d | 104d | PROCUREMENT<$50K 60; MECH ENG [80 h]; MECH TECH [880 h]; MECH DES [240 h] | 59,787.61 | CHUDAKOV | 1 | 1 | D | 07-024 | EUGENE C |  | 11-004 | 11-006 | 11-036 | 11-053 | 12-054F |  |  |  |  |  |  |  |  | 3 | 10-042 |  |  |  |  |  |  |
| 151173f |  | Install solenoid vacuum manifold | 51d | 2012-06-01 | 2012-08-13 | 151173d5 FS-20d, 151173d FS-20d | 217d | 126d | MECH TECH [204 h] | 9,065.76 | CHUDAKOV | 1 | 1 | D |  | EUGENE C |  |  |  |  |  |  |  |  |  |  |  |  |  |  | 3 |  | 12-021 |  |  |  |  |  |
| 151175 |  | Connect Coils (SOLENOID) (IPL) | 45d | 2012-07-27 | 2012-09-28 | 151172, 13321070 FS-45d, 151170 | 8d | 0d | PROCUREMENT<$50K 60; MECH ENG [40 h]; MECH TECH [320 h]; MECH DES [40 h] | 20,122.41 | CHUDAKOV | 1 | 1 | D | 07-024 | EUGENE C |  | 11-004 | 11-006 | 11-036 |  | 12-054 |  |  |  |  |  | 09-014 |  |  | 3 | 10-042 |  |  |  |  |  |  |

Notes:
- 151045: Explanation: IPL from 6 GeV / 551400LOE
- 151050: Explanation: IPL from 6 GeV 551360

| ID | WBS | Activity | Type | Duration | Start | Finish | Predecessors | Total float | Free float | Calendar | Resources | Cost | RESP - Responsibility | STRT%COMP for CM EVM | FNSH%COMP for CM EVM | 12 GeV 3rd level Critical Path | HALL D Related Milestones | CR 07-024 | CAM RESPONSIBLE | CR 09-014 | CR 10-042 | CR 11-004 | CR 11-006 | CR 11-036 | CR 12-053 | CR 12-054 | Milestone Level | 12 GeV 2nd level Critical Path | CR 13-014 | ReBaseline Actuals Adjustment | Original Activity ID Rebaseline | EVMS Reporting Codes | CR 12-021 | BOE Labor | CR 13-015 | Post Rebaseline | CR 12-040 | CR 13-007 | Over Under Fixed | CR 08-016 | CR 11-026 | CR 12-034 | BOE Procurement | Obligated Prior to Rebaseline | CR 08-058 | CR 09-027 | CR 09-027 Repair | Advance Purchase Plan > 500K | CR 08-035 | CR 09-046 | CR 10-024 | CR 11-001 | CR 09-012 | CR 08-052 | CR 12-055 | CR 12-001 |
| --- | --- | --- | --- | --- | --- | --- | --- | --- | --- | --- | --- | --- | --- | --- | --- | --- | --- | --- | --- | --- | --- | --- | --- | --- | --- | --- | --- | --- | --- | --- | --- | --- | --- | --- | --- | --- | --- | --- | --- | --- | --- | --- | --- | --- | --- | --- | --- | --- | --- | --- | --- | --- | --- | --- | --- | --- |
| 151185 |  | Elect Test Solenoid (SOLENOID) |  | 10d | 2012-09-17 | 2012-09-28 | 151175 FS-10d | 8d | 0d |  | MECH DES [97.2 h]; MECH ENG [97.2 h]; MECH TECH [97.2 h] | 15,817.35 | CHUDAKOV | 1 | 1 | 3 | D | 07-024 | EUGENE C | 09-014 | 10-042 | 11-004 | 11-006 | 11-036 | 12-053 | 12-054 |  |  |  |  |  |  |  |  |  |  |  |  |  |  |  |  |  |  |  |  |  |  |  |  |  |  |  |  |  |  |
| 151250M |  | Installtn of Solenoid Comptd (SOLENOID) | milestone | 0d | 2013-02-20 | 2013-02-20 | 151173f, 151173g, 151011E, 18241040, 18241000, 18241005 | 91d | 0d |  |  |  | CHUDAKOV | 1 | 1 |  | D |  | EUGENE C | 09-014 | 10-042 | 11-004 |  | 11-036 |  |  | 6 | 2 |  |  |  |  |  |  |  |  |  |  |  |  |  |  |  |  |  |  |  |  |  |  |  |  |  |  |  |  |
| 151255 |  | Re-Baseline Actuals Adjustment |  | 1d | 2013-08-30 | 2013-08-30 | 9-130M FS+227d | 20d |  |  | PROCUREMENT>$50K 69 NO ESCALATION | 1,135,844.22 | CHUDAKOV | 1 | 1 |  |  |  | EUGENE C |  |  |  |  |  |  |  |  |  | 13-014 | ADJ |  |  |  |  |  |  |  |  |  |  |  |  |  |  |  |  |  |  |  |  |  |  |  |  |  |  |
| 251173f |  | Install solenoid vacuum manifold |  | 10d | 2013-09-03 | 2013-09-16 | 9-130M FS+228d | 64d | 0d | 8/5 M-F w/JLAB Holidays ReBaseline | MECH TECH [86.7 h] | 3,976.06 | CHUDAKOV | 1 | 1 | 3 | D |  | EUGENE C |  |  |  |  |  |  |  |  |  |  |  | 251173f | S | 12-021 | PE | 13-015 | PR |  |  |  |  |  |  |  |  |  |  |  |  |  |  |  |  |  |  |  |  |
| 251195 |  | Repair Solenoid Vac Leaks |  | 4d | 2013-09-03 | 2013-09-06 | 9-130M FS+228d | 0d |  | 8/5 M-F w/JLAB Holidays ReBaseline | MECH TECH [26.94 h]; MECH ENG [9.6 h]; MECH DES [14.08 h]; SR STAFF [6.4 h] | 3,376.24 | CHUDAKOV | 1 | 1 | 3 | D | 07-024 | EUGENE C | 09-014 | 10-042 | 11-004 | 11-006 | 11-036 |  | 12-054 |  |  |  |  | 251195 | S |  | PE | 13-015 | PR | 12-040 | 13-007 |  |  |  |  |  |  |  |  |  |  |  |  |  |  |  |  |  |  |
| 251666 |  | Consultant Fee (Quench Study WS) |  | 20d | 2013-09-03 | 2013-09-30 | 9-130M FS+228d | 247d |  | 8/5 M-F w/JLAB Holidays ReBaseline | PROCUREMENT<$50K 60 | 6,100 | CHUDAKOV | 1 | 1 |  | D |  | EUGENE C | 09-014 |  |  | 11-006 |  |  | 12-054 |  |  |  |  | 25213005 | D | 12-021 |  | 13-015 | PR |  | 13-007F | y | 08-016 | 11-026 | 12-034 | VQ | OB |  |  |  |  |  |  |  |  |  |  |  |  |
| 251250M |  | Installtn of Solenoid Comptd (SOLENOID) | milestone | 0d | 2013-09-16 | 2013-09-16 | 251173f | 64d | 10d | 8/5 M-F w/JLAB Holidays ReBaseline |  |  | CHUDAKOV | 1 | 1 |  | D |  | EUGENE C | 09-014 | 10-042 | 11-004 |  | 11-036 |  |  | 6 | 2 |  |  | 251250M | M |  |  | 13-015 | PR |  | 13-007 |  |  |  |  |  |  |  |  |  |  |  |  |  |  |  |  |  |  |
|  | 2 | **1.5.2 DETECTORS** |  |  | 2008-12-01 | 2014-04-21 |  |  |  |  |  |  |  |  |  |  |  |  |  |  |  |  |  |  |  |  |  |  |  |  |  |  |  |  |  |  |  |  |  |  |  |  |  |  |  |  |  |  |  |  |  |  |  |  |  |  |
|  | 1 | **1.5.2.1 TRACKING** |  |  | 2009-01-02 | 2014-04-21 |  |  |  |  |  |  |  |  |  |  |  |  |  |  |  |  |  |  |  |  |  |  |  |  |  |  |  |  |  |  |  |  |  |  |  |  |  |  |  |  |  |  |  |  |  |  |  |  |  |  |
|  | 1 | **1.5.2.1.1 FORWARD CHAMBERS** |  |  | 2009-01-02 | 2014-03-31 |  |  |  |  |  |  |  |  |  |  |  |  |  |  |  |  |  |  |  |  |  |  |  |  |  |  |  |  |  |  |  |  |  |  |  |  |  |  |  |  |  |  |  |  |  |  |  |  |  |  |
| 15211009E |  | FY09 Travel (FWD Chambers) |  | 189d | 2009-01-02 | 2009-09-30 | 15211009EX | 64d | 0d |  | TRAVEL | 982.69 | CHUDAKOV | 1 | 1 |  | D | 07-024 | EUGENE C |  |  |  | 11-006 |  |  | 12-054F |  |  |  |  |  |  |  |  |  |  |  |  |  |  | 11-026 |  |  |  | 08-058 |  |  |  |  |  |  |  |  |  |  |  |
| 15211000a |  | Procurement for Testing the Assembly Proceedure (FWD Chambers) |  | 65d | 2009-06-01 | 2009-08-31 | 9-090M FS+162d | 850d | 41d |  | PROCUREMENT<$50K 60 | 22,000 | CHUDAKOV | 1 | 1 |  | D | 07-024 | EUGENE C | 09-014 |  |  | 11-006 |  |  | 12-054F |  | 2 |  |  |  |  |  |  |  |  |  |  |  |  | 11-026 |  |  |  |  | 09-027 | 09-027 |  |  |  |  |  |  |  |  |  |
| 15211000b |  | Testing the Assembly Procedure (FWD Chambers) |  | 86d | 2009-06-01 | 2009-09-30 | 15211000a FS-106d, 9-090M FS+162d | 809d | 54d |  | MECH TECH [560 h]; ELEC TECH [160 h]; MECH ENG [160 h] | 39,288.8 | CHUDAKOV | 1 | 1 |  | D | 07-024 | EUGENE C | 09-014 |  |  | 11-006 |  |  | 12-054F |  | 2 |  |  |  |  |  |  |  |  |  |  |  |  | 11-026 |  |  |  |  | 09-027 | 09-027 |  |  |  |  |  |  |  |  |  |
| 15211001a |  | Prepare Procurements/Fabrication Packages 2010 (FWD Chambers) |  | 86d | 2009-06-01 | 2009-09-30 | 9-090M FS+162d | 755d | 0d |  | MECH DES [640 h]; MECH ENG [120 h] | 35,714.8 | CHUDAKOV | 1 | 1 |  | D | 07-024 | EUGENE C | 09-014 |  |  | 11-006 |  |  | 12-054F |  | 2 |  |  |  |  |  |  |  |  |  |  |  |  | 11-026 |  |  |  |  | 09-027 | 09-027 |  |  |  |  |  |  |  |  |  |
| 15211010E |  | FY10 Travel (FWD Chambers) |  | 248d | 2009-10-01 | 2010-09-30 | 15211009E | 146d | 0d |  | TRAVEL | 1,330.62 | CHUDAKOV | 1 | 1 |  | D | 07-024 | EUGENE C |  |  |  | 11-006 |  |  | 12-054F |  |  |  |  |  |  |  |  |  |  |  |  |  |  | 11-026 |  |  |  |  |  |  |  |  |  |  |  |  |  |  |  |
| 15211001b |  | Evaluate Procurements 2010 (FWD Chambers) |  | 6d | 2009-12-18 | 2010-01-04 | 15211000b, 15211001a FS+54d | 755d | 496d |  | MECH ENG [40 h] | 2,634 | CHUDAKOV | 1 | 1 |  | D | 07-024 | EUGENE C | 09-014 |  |  | 11-006 |  |  | 12-054F |  | 2 |  |  |  |  |  |  |  |  |  |  |  |  | 11-026 |  |  |  |  | 09-027 | 09-027 |  |  |  |  |  |  |  |  |  |
| 15211001c |  | Track Fabrication 2010 (FWD Chambers) |  | 130d | 2010-01-05 | 2010-07-09 | 9-100M FS+60d | 745d | 486d |  | MECH ENG [40 h] | 2,634 | CHUDAKOV | 1 | 1 |  | D | 07-024 | EUGENE C | 09-014 |  |  | 11-006 |  |  | 12-054F |  | 2 |  |  |  |  |  |  |  |  |  |  |  |  | 11-026 |  |  |  |  | 09-027 | 09-027 |  |  |  |  |  |  |  |  |  |
| 15211002a |  | Engineering Support for Assembly FY10 (FWD Chambers) |  | 188d | 2010-01-05 | 2010-09-30 | 15211009E FS+60d | 64d | 0d |  | MECH DES [240 h]; MECH ENG [240 h] | 26,661.6 | CHUDAKOV | 1 | 1 |  | D | 07-024 | EUGENE C |  |  |  | 11-006 |  |  | 12-054F |  |  |  |  |  |  |  |  |  |  |  |  |  |  | 11-026 |  |  |  |  | 09-027 | 09-027 |  |  |  |  |  |  |  |  |  |
| 15211020 |  | ProcFirst Article PC Boards Cathode Kapton Foil (FWD Chambers) |  | 102d | 2010-01-05 | 2010-05-28 | 12321018M, 9-100M FS+60d | 63d | 0d |  | PROCUREMENT<$50K 60 | 44,599.7 | CHUDAKOV | 1 | 1 |  | D |  | EUGENE C | 09-014 | 10-042 |  | 11-006 |  |  | 12-054F |  |  |  |  |  |  |  |  |  |  |  |  |  |  | 11-026 |  |  |  |  |  |  | APP |  |  |  |  |  |  |  |  |
| 15211022 |  | Procuremnt of Rigid Flex Assemblies (FWD Chambers) |  | 80d | 2010-01-05 | 2010-04-28 | 9-100M FS+60d, 12321018M | 300d | 237d |  | PROCUREMENT<$50K 60 | 29,814.89 | CHUDAKOV | 1 | 1 |  | D |  | EUGENE C | 09-014 |  |  | 11-006 |  |  | 12-054F |  |  |  |  |  |  |  |  |  |  |  |  |  |  | 11-026 |  |  |  |  |  |  | APP | 08-035 |  |  |  |  |  |  |  |
| 15211025 |  | Proc Wire (Field, sense) (FWD Chambers) |  | 130d | 2010-01-05 | 2010-07-09 | 9-100M FS+60d, 12321018M | 176d | 0d |  | PROCUREMENT<$50K 60 | 14,284.21 | CHUDAKOV | 1 | 1 |  | D |  | EUGENE C | 09-014 |  |  | 11-006 |  |  | 12-054F |  |  |  |  |  |  |  |  |  |  |  |  |  |  | 11-026 |  |  |  |  |  |  | APP |  |  |  |  |  |  |  |  |
| 15211030 |  | Proc First Article On-Chamb Electrnc's (capacitors, resistors) (FWD Chambers) |  | 102d | 2010-01-05 | 2010-05-28 | 9-100M FS+60d | 159d | 0d |  | PROCUREMENT<$50K 60 | 15,932.39 | CHUDAKOV | 1 | 1 |  | D |  | EUGENE C |  | 10-042 |  | 11-006 |  |  | 12-054F |  |  |  |  |  |  |  |  |  |  |  |  |  |  | 11-026 |  |  |  |  |  |  | APP |  |  |  |  |  |  |  |  |
| 15211100 |  | Fab Setup (FWD Chambers) |  | 110d | 2010-01-05 | 2010-06-10 | 9-100M FS+60d, 15211002a FS-190d | 225.5d | 116d |  | MECH TECH [880 h]; MECH ENG [880 h] | 94,679.2 | CHUDAKOV | 1 | 1 |  | D |  | EUGENE C | 09-014 | 10-042 |  | 11-006 |  |  | 12-054F |  |  |  |  |  |  |  |  |  |  |  |  |  |  | 11-026 |  |  |  |  |  |  |  |  |  |  |  |  |  |  |  |
| 15211005 |  | Proc Chamb Frames (G10) (FWD Chambers) |  | 135d | 2010-05-14 | 2010-11-23 | 9-100M FS+151d, 12321018M | 109.5d | 0d |  | PROCUREMENT<$50K 60 NO ESCALATION FY11; PROCUREMENT>$50K 69 NO ESCALATION FY11 | 152,731.16 | CHUDAKOV | 1 | 1 |  | D |  | EUGENE C | 09-014 | 10-042 |  | 11-006 |  |  | 12-054F |  |  |  |  |  |  |  |  |  |  |  |  |  |  | 11-026 |  |  |  |  |  |  | APP | 08-035 |  |  |  |  |  |  |  |
| 15211015 |  | Proc PC Boards (G10) (FWD Chambers) |  | 89d | 2010-05-14 | 2010-09-20 | 12321018M, 9-100M FS+151d | 163.5d | 0d |  | PROCUREMENT<$50K 60; PROCUREMENT>$50K 69 | 97,791.89 | CHUDAKOV | 1 | 1 |  | D |  | EUGENE C | 09-014 | 10-042 |  | 11-006 |  |  | 12-054F |  |  |  |  |  |  |  |  |  |  |  |  |  |  | 11-026 |  |  |  |  |  |  | APP | 08-035 | 09-046 |  |  |  |  |  |  |
| 15211020a |  | Proc Production PC Boards Cathode Kapton Foil (FWD Chambers) |  | 130d | 2010-05-14 | 2010-11-16 | 15211020 FS-11d | 63d | 0d |  | PROCUREMENT<$50K 60 NO ESCALATION FY11; PROCUREMENT>$50K 69 NO ESCALATION FY11 | 90,550.89 | CHUDAKOV | 1 | 1 |  | D |  | EUGENE C | 09-014 | 10-042 |  | 11-006 |  |  | 12-054F |  |  |  |  |  |  |  |  |  |  |  |  |  |  | 11-026 |  |  |  |  |  |  | APP |  |  |  |  |  |  |  |  |
| 15211030a |  | Proc Production On-Chamb Electrnc's (capacitors, resistors) (FWD Chambers) |  | 130d | 2010-05-14 | 2010-11-16 | 15211030 FS-11d | 159d | 96d |  | PROCUREMENT<$50K 60 NO ESCALATION FY11 | 15,932.39 | CHUDAKOV | 1 | 1 |  | D |  | EUGENE C |  | 10-042 |  | 11-006 |  |  | 12-054F |  |  |  |  |  |  |  |  |  |  |  |  |  |  | 11-026 |  |  |  |  |  |  | APP |  |  |  |  |  |  |  |  |
| 15211035 |  | Proc Chamb Preamps (ASIC Dsgn) (FWD Chambers) Labor FY10 |  | 68d | 2010-06-25 | 2010-09-30 | 9-100M FS+180d | 221d | 0d |  | PD UNIV STUDNT [418.46 h] | 4,192.97 | CHUDAKOV | 1 | 1 |  | D |  | EUGENE C | 09-014 |  |  | 11-006 |  |  | 12-054F |  |  |  |  |  |  |  |  |  |  |  |  |  |  | 11-026 |  |  |  |  |  |  | APP | 08-035 |  | 10-024 | 11-001 |  |  |  |  |
| 15211001d |  | Acceptance Checks/Documentation 2010 (FWD Chambers) |  | 44d | 2010-07-01 | 2010-09-01 | 9-100M FS+184d | 709d | 450d |  | MECH ENG [40 h] | 2,634 | CHUDAKOV | 1 | 1 |  | D | 07-024 | EUGENE C | 09-014 |  |  | 11-006 |  |  | 12-054F |  | 2 |  |  |  |  |  |  |  |  |  |  |  |  | 11-026 |  |  |  |  | 09-027 | 09-027 |  |  |  |  |  |  |  |  |  |
| 15211090 |  | Test Wire (Field, sense) (FWD Chambers) FY10 |  | 57.5d | 2010-07-12 | 2010-09-30 | 15211025 | 176d | 0d |  | ELEC TECH [464 h] | 19,232.8 | CHUDAKOV | 1 | 1 |  | D |  | EUGENE C | 09-014 |  |  | 11-006 |  |  | 12-054F |  |  |  |  |  |  |  |  |  |  |  |  |  |  | 11-026 |  |  |  |  |  |  |  |  |  |  | 11-001 |  |  |  |  |
| 15211080 |  | Test PC Boards (G10) (FWD Chambers) FY10 |  | 7.5d | 2010-09-21 | 2010-09-30 | 15211015 | 163.5d | 0d |  | ELEC TECH [64 h] | 2,652.8 | CHUDAKOV | 1 | 1 |  | D |  | EUGENE C | 09-014 | 10-042 |  | 11-006 |  |  | 12-054F |  |  |  |  |  |  |  |  |  |  |  |  |  |  | 11-026 |  |  |  |  |  |  |  |  |  |  | 11-001 |  |  |  |  |
| 15211080a |  | Test PC Boards (G10) (FWD Chambers) FY11 |  | 29d | 2010-09-30 | 2010-11-10 | 15211080 | 163.5d | 0d |  | ELEC TECH [228 h] | 9,746.37 | CHUDAKOV | 1 | 1 |  | D |  | EUGENE C | 09-014 | 10-042 |  | 11-006 |  |  | 12-054F |  |  |  |  |  |  |  |  |  |  |  |  |  |  | 11-026 |  |  |  |  |  |  |  |  |  |  | 11-001 |  |  |  |  |
| 15211090a |  | Test Wire (Field, sense) (FWD Chambers) FY11 |  | 16.5d | 2010-09-30 | 2010-10-22 | 15211090 | 176d | 113d |  | ELEC TECH [124 h] | 5,298.52 | CHUDAKOV | 1 | 1 |  | D |  | EUGENE C | 09-014 |  |  | 11-006 |  |  | 12-054F |  |  |  |  |  |  |  |  |  |  |  |  |  |  | 11-026 |  |  |  |  |  |  |  |  |  |  | 11-001 |  |  |  |  |
| 15211002b |  | Engineering Support for Assembly FY11 (FWD Chambers) |  | 248d | 2010-10-01 | 2011-09-30 | 15211002a | 64d | 0d |  | MECH DES [160 h]; MECH ENG [20 h] | 8,827.8 | CHUDAKOV | 1 | 1 |  | D | 07-024 | EUGENE C |  |  |  | 11-006 |  |  | 12-054F |  |  |  |  |  |  |  |  |  |  |  |  |  |  | 11-026 |  |  |  |  | 09-027 | 09-027 |  |  |  |  |  |  |  |  |  |
| 15211011E |  | FY11 Travel (FWD Chambers) |  | 248d | 2010-10-01 | 2011-09-30 | 15211010E | 146d | 0d |  | TRAVEL | 1,373.07 | CHUDAKOV | 1 | 1 |  | D | 07-024 | EUGENE C |  |  |  | 11-006 |  |  | 12-054F |  |  |  |  |  |  |  |  |  |  |  |  |  |  | 11-026 |  |  |  |  |  |  |  |  |  |  |  |  |  |  |  |
| 15211035a |  | Proc Chamb Preamps (ASIC Dsgn) (FWD Chambers) Labor FY11 |  | 62d | 2010-10-01 | 2011-01-06 | 15211035 | 221d | 186d |  | PD UNIV STUDNT [381.54 h] | 3,945.12 | CHUDAKOV | 1 | 1 |  | D |  | EUGENE C | 09-014 |  |  | 11-006 |  |  | 12-054F |  |  |  |  |  |  |  |  |  |  |  |  |  |  | 11-026 |  |  |  |  |  |  | APP | 08-035 |  | 10-024 | 11-001 |  |  |  |  |
| 15211140 |  | G10 PC Board Prep (FWD Chambers) |  | 36.5d | 2010-11-10 | 2011-01-11 | 15211080a | 202d | 4d |  | MECH TECH [292 h] | 12,576.44 | CHUDAKOV | 1 | 1 |  | D |  | EUGENE C | 09-014 | 10-042 |  | 11-006 |  |  | 12-054F |  |  |  |  |  |  |  |  |  |  |  |  |  |  | 11-026 |  |  |  |  |  |  |  |  |  |  |  |  |  |  |  |
| 15211085 |  | Test PC Boards (Flex) (FWD Chambers) |  | 73.5d | 2010-11-17 | 2011-03-14 | 15211020, 15211020a | 63d | 0d |  | ELEC TECH [588 h] | 25,148.76 | CHUDAKOV | 1 | 1 |  | D |  | EUGENE C | 09-014 | 10-042 |  | 11-006 |  |  | 12-054F |  |  |  |  |  |  |  |  |  |  |  |  |  |  | 11-026 |  |  |  |  |  |  |  |  |  |  |  |  |  |  |  |
| 15211155 |  | Mount on-Chamb Electrnc's (FWD Chambers) |  | 26d | 2010-11-17 | 2010-12-31 | 9-110M FS+33d | 430d | 410d |  | ELEC TECH [209.42 h] | 8,956.89 | CHUDAKOV | 1 | 1 |  | D |  | EUGENE C |  | 10-042 |  | 11-006 |  |  | 12-054F |  |  |  |  |  |  |  |  |  |  |  |  |  |  | 11-026 |  |  |  |  |  |  |  |  |  |  |  | 09-012 |  |  |  |
| 15211105 |  | Wire Chamb Frames Prep (FWD Chambers) |  | 36.5d | 2010-11-24 | 2011-01-26 | 15211100, 15211002a FS-55d, 15211005, 197111030M | 109.5d | 45.5d |  | MECH TECH [292 h] | 12,576.44 | CHUDAKOV | 1 | 1 |  | D |  | EUGENE C | 09-014 | 10-042 |  | 11-006 |  |  | 12-054F |  |  |  |  |  |  |  |  |  |  |  |  |  |  | 11-026 |  |  |  |  |  |  |  |  |  |  |  |  |  |  |  |
| 15211102 |  | Set-up Clean Room for Production |  | 34d | 2011-01-04 | 2011-02-22 | 9-110M FS+59d | 91d | 27d |  | MECH TECH [480 h]; MECH ENG [240 h] | 36,981.6 | CHUDAKOV | 1 | 1 |  | D |  | EUGENE C | 09-014 | 10-042 |  | 11-006 |  |  | 12-054F |  |  |  |  |  |  |  |  |  |  |  |  |  |  | 11-026 |  |  |  |  |  |  |  |  |  |  |  |  |  |  |  |
| 15211145 |  | Procurement of Consumables for Fab (2011) (FWD Chambers) |  | 189d | 2011-01-04 | 2011-09-30 | 15211140 FS-10d, 9-110M FS+59d | 198d | 178d |  | PROCUREMENT<$50K 60 | 82,200 | CHUDAKOV | 1 | 1 |  | D |  | EUGENE C |  | 10-042 |  | 11-006 |  |  | 12-054F |  |  |  |  |  |  |  |  |  |  |  |  |  |  | 11-026 |  |  |  |  |  |  | APP | 08-035 |  | 10-024 |  |  | 08-052 |  |  |
| 15211050 |  | Proc Cables,Connectors (HV, LV, Signal, Gas) (FWD Chambers) |  | 130d | 2011-01-05 | 2011-07-11 | 9-110M FS+60d | 172d | 0d |  | PROCUREMENT>$50K 69; PROCUREMENT<$50K 60 | 86,171.57 | CHUDAKOV | 1 | 1 |  | D |  | EUGENE C |  | 10-042 |  | 11-006 |  |  | 12-054F |  |  |  |  |  |  |  |  |  |  |  |  |  |  | 11-026 |  |  |  |  |  |  | APP | 08-035 |  |  |  |  |  |  |  |
| 15211070 |  | Proc Gas Connections (FWD Chambers) |  | 130d | 2011-01-05 | 2011-07-11 | 9-110M FS+60d | 236d | 199d |  | PROCUREMENT<$50K 60; PROCUREMENT>$50K 69 | 56,691.82 | CHUDAKOV | 1 | 1 |  | D |  | EUGENE C |  |  |  | 11-006 |  |  | 12-054F |  |  |  |  |  |  |  |  |  |  |  |  |  |  | 11-026 |  |  |  |  |  |  | APP |  |  |  |  |  |  |  |  |
| 15211035b |  | ASIC Fabrication (FDC&CDC) |  | 60d | 2011-03-07 | 2011-05-27 | 1546005, 9-100M FS+180d | 77d | 0d |  | PROCUREMENT<$50K 60; PROCUREMENT>$50K 69 | 160,000 | CHUDAKOV | 1 | 1 |  | D |  | EUGENE C | 09-014 |  |  | 11-006 |  |  | 12-054F |  |  |  |  |  |  |  |  |  |  |  |  |  |  | 11-026 |  |  |  |  |  |  | APP | 08-035 |  | 10-024 | 11-001 |  |  |  |  |
| 15211163 |  | Manufacture All Cables & QA (FWD Chambers) |  | 110d | 2011-03-14 | 2011-08-16 | 15211050 FS-84d | 172d | 137d |  | ELEC TECH [880 h]; MECH TECH [880 h] | 75,539.2 | CHUDAKOV | 1 | 1 |  | D |  | EUGENE C |  | 10-042 |  | 11-006 |  |  | 12-054F |  |  |  |  |  |  |  |  |  |  |  |  |  |  | 11-026 |  |  |  |  |  |  |  |  |  |  |  |  |  |  |  |
| 15211120 |  | Cathode Frame Inspection (FWD Chambers) |  | 22d | 2011-03-15 | 2011-04-13 | 15211002b FS-233d, 15211100, 15211085 FS+0.5d | 63d | 0d |  | MECH TECH [176 h] | 7,580.32 | CHUDAKOV | 1 | 1 |  | D |  | EUGENE C | 09-014 | 10-042 |  | 11-006 |  |  | 12-054F |  |  |  |  |  |  |  |  |  |  |  |  |  |  | 11-026 |  |  |  |  |  |  |  |  |  |  |  |  |  |  |  |
| 15211125 |  | Cell #1Assy. (FWD Chambers) |  | 22d | 2011-04-01 | 2011-05-02 | 15211100, 15211105, 15211002b FS-128d, 15211102 | 64d | 1d |  | ELEC TECH [160 h]; SCIENTIST [160 h]; MECH TECH [720 h]; MECH DES [160 h]; MECH ENG [240 h] | 72,579.2 | CHUDAKOV | 1 | 1 |  | D |  | EUGENE C | 09-014 | 10-042 |  | 11-006 |  |  | 12-054F |  |  |  |  |  |  |  |  |  |  |  |  |  |  | 11-026 |  |  |  |  |  |  |  |  |  |  |  |  |  |  |  |
| 15211126 |  | Package #1 Fabrication (FWD Chambers) |  | 119d | 2011-04-14 | 2011-09-30 | 15211120, 15211080a, 15211090a, 15211022, 15211125 FS-14d, 15211002b FS-245d, 15211030a | 63d | 0d |  | MECH DES [160 h]; MECH ENG [320 h]; SCIENTIST [160 h]; MECH TECH [3400 h]; ELEC TECH [160 h] | 193,442.8 | CHUDAKOV | 1 | 1 |  | D |  | EUGENE C | 09-014 | 10-042 |  | 11-006 |  |  | 12-054F |  |  |  |  |  |  |  |  |  |  |  |  |  |  | 11-026 |  |  |  |  |  |  |  |  |  |  |  |  |  |  |  |
| 15211163a |  | Support for procurement of parts for gas system (FWD Chambers) |  | 66d | 2011-06-01 | 2011-09-01 | 9-110M FS+162d | 198d | 161d |  | SCIENTIST [160 h] | 10,948.8 | CHUDAKOV | 1 | 1 |  | D |  | EUGENE C |  |  |  | 11-006 |  |  | 12-054F |  |  |  |  |  |  |  |  |  |  |  |  |  |  | 11-026 |  |  |  |  |  |  |  |  |  |  |  |  |  |  |  |
| 15211002c |  | Additional Engineering Support for Assembly FY12 (FWD Chambers) |  | 84d | 2011-06-03 | 2011-09-30 | 15211002b FS-84d | 628d | 596d |  | MECH DES [160 h]; MECH ENG [20 h] | 8,827.8 | CHUDAKOV | 1 | 1 |  | D | 07-024 | EUGENE C |  |  |  | 11-006 |  |  | 12-054F |  |  |  |  |  |  |  |  |  |  |  |  |  |  | 11-026 |  |  |  |  | 09-027 | 09-027 |  |  |  |  |  |  |  |  |  |
| 15211060 |  | Proc Cooling Sys (FWD Chambers) Part A |  | 64d | 2011-07-01 | 2011-09-30 | 9-110M FS+184d | 346d | 326d |  | PROCUREMENT<$50K 60 | 14,472.41 | CHUDAKOV | 1 | 1 |  | D |  | EUGENE C |  |  |  | 11-006 |  |  | 12-054F |  |  |  |  |  |  |  |  |  |  |  |  |  |  | 11-026 |  |  |  |  |  |  | APP |  |  |  |  |  |  | 12-055 |  |
| 15211060a |  | Proc Cooling Sys (FWD Chambers) Part B |  | 64d | 2011-07-01 | 2011-09-30 | 9-110M FS+184d | 346d | 326d |  | PROCUREMENT<$50K 60 | 10,472 | CHUDAKOV | 1 | 1 |  | D |  | EUGENE C |  |  |  | 11-006 |  |  | 12-054F |  |  |  |  |  |  |  |  |  |  |  |  |  |  | 11-026 |  |  |  |  |  |  | APP |  |  |  |  |  |  | 12-055 |  |
| 15211130 |  | Package #2 Fabrication (FWD Chambers) FY11 |  | 9d | 2011-09-20 | 2011-09-30 | 15211126 FS-9d | 63d | 0d |  | MECH ENG [23.23 h]; SCIENTIST [13.27 h]; ELEC TECH [13.27 h]; MECH TECH [282.03 h]; MECH DES [6.64 h] | 15,511.1 | CHUDAKOV | 1 | 1 |  | D |  | EUGENE C | 09-014 | 10-042 |  | 11-006 |  |  | 12-054F |  |  |  |  |  |  |  |  |  |  |  |  |  |  | 11-026 |  |  |  |  |  |  |  |  |  |  |  |  |  |  | 12-001 |
| 15211012E |  | FY12 Travel (FWD Chambers) |  | 247d | 2011-10-03 | 2012-09-28 | 15211011E | 146d | 126d |  | TRAVEL | 1,418.05 | CHUDAKOV | 1 | 1 |  | D | 07-024 | EUGENE C |  |  |  | 11-006 |  |  | 12-054F |  |  |  |  |  |  |  |  |  |  |  |  |  |  | 11-026 |  |  |  |  |  |  |  |  |  |  |  |  |  |  |  |
| 15211075 |  | Proc Supprt Frame (FWD Chambers) Part A |  | 87d | 2011-10-03 | 2012-02-13 | 15211001b FS-60d, 15211001c FS-180d, 15211001d FS-182d, 9-120M | 259d | 239d |  | PROCUREMENT<$50K 60 | 37,476 | CHUDAKOV | 1 | 1 |  | D |  | EUGENE C | 09-014 | 10-042 |  | 11-006 |  |  | 12-054F |  |  |  |  |  |  |  |  |  |  |  |  |  |  | 11-026 |  |  |  |  |  |  | APP |  | 09-046 |  |  |  |  | 12-055 |  |
| 15211075a |  | Proc Supprt Frame (FWD Chambers) Part B |  | 87d | 2011-10-03 | 2012-02-13 | 15211001c FS-180d, 15211001b FS-60d, 9-120M, 15211001d FS-182d | 259d | 239d |  | PROCUREMENT<$50K 60 | 3,800 | CHUDAKOV | 1 | 1 |  | D |  | EUGENE C | 09-014 | 10-042 |  | 11-006 |  |  | 12-054F |  |  |  |  |  |  |  |  |  |  |  |  |  |  | 11-026 |  |  |  |  |  |  | APP |  | 09-046 |  |  |  |  | 12-055 |  |
| 15211094 |  | Acceptance Preamp Daughter Board (FWD Chambers) |  | 178d | 2011-10-03 | 2012-06-22 | 15211035b, 15211035a, 9-120M | 35d | 15d |  |  |  | CHUDAKOV | 1 | 1 |  | D |  | EUGENE C | 09-014 |  |  | 11-006 |  |  | 12-054F |  |  |  |  |  |  |  |  |  |  |  |  |  |  | 11-026 |  |  |  |  |  |  |  |  |  |  |  |  |  |  |  |
| 15211130a |  | Package #2 Fabrication (FWD Chambers) FY12 |  | 100.5d | 2011-10-03 | 2012-03-05 | 15211130 | 63d | 0d |  | MECH TECH [3117.97 h]; MECH DES [73.36 h]; MECH ENG [256.77 h]; SCIENTIST [146.73 h]; ELEC TECH [146.73 h] | 176,936.85 | CHUDAKOV | 1 | 1 |  | D |  | EUGENE C | 09-014 | 10-042 |  | 11-006 |  |  | 12-054F |  |  |  |  |  |  |  |  |  |  |  |  |  |  | 11-026 |  |  |  |  |  |  |  |  |  |  |  |  |  |  | 12-001 |
| 15211190 |  | Procurement of Consumables for Fab (2012) (FWD Chambers) |  | 247d | 2011-10-03 | 2012-09-28 | 9-120M | 71d | 0d |  | PROCUREMENT<$50K 60 | 11,866.85 | CHUDAKOV | 1 | 1 |  | D |  | EUGENE C | 09-014 | 10-042 |  | 11-006 |  |  | 12-054F |  |  |  |  |  |  |  |  |  |  |  |  |  |  | 11-026 |  |  |  |  |  |  |  |  |  |  |  |  |  |  |  |
| 15211135 |  | Package #3 Fabrication (FWD Chambers) |  | 116d | 2012-02-21 | 2012-08-03 | 15211130a FS-9d | 63d | 0d |  | SCIENTIST [160 h]; ELEC TECH [160 h]; MECH DES [80 h]; MECH ENG [280 h]; MECH TECH [3400 h] | 192,941.6 | CHUDAKOV | 1 | 1 |  | D |  | EUGENE C | 09-014 | 10-042 |  | 11-006 |  |  | 12-054F |  |  |  |  |  |  |  |  |  |  |  |  |  |  | 11-026 |  |  |  |  |  |  |  |  |  |  |  |  |  |  |  |
| 15211249 |  | Construct/Install/Test HV Sys (FWD Chambers) |  | 68d | 2012-03-12 | 2012-06-15 | 9-120M FS+105d, 15211163 | 35d | 15d |  | ELEC TECH [296 h]; MECH TECH [296 h] | 26,216.72 | CHUDAKOV | 1 | 1 |  | D |  | EUGENE C |  | 10-042 |  | 11-006 |  |  | 12-054F |  |  |  |  |  |  |  |  |  |  |  |  |  |  | 11-026 |  |  |  |  |  |  |  |  |  |  |  |  |  |  |  |
| 15211250 |  | Construct/Install/Test LV Sys ((FWD Chambers) |  | 68d | 2012-03-12 | 2012-06-15 | 9-120M FS+105d | 35d | 15d |  | ELEC TECH [296 h]; MECH TECH [296 h] | 26,216.72 | CHUDAKOV | 1 | 1 |  | D |  | EUGENE C |  |  |  | 11-006 |  |  | 12-054F |  |  |  |  |  |  |  |  |  |  |  |  |  |  | 11-026 |  |  |  |  |  |  |  |  |  |  |  |  |  |  |  |
| 15211095 |  | Test Electrnc's (FWD Chambers) |  | 127d | 2012-03-26 | 2012-09-21 | 9-120M FS+115d | 36d | 16d |  | ELEC TECH [880 h] | 38,834.4 | CHUDAKOV | 1 | 1 |  | D |  | EUGENE C | 09-014 |  |  | 11-006 |  |  | 12-054F |  |  |  |  |  |  |  |  |  |  |  |  |  |  | 11-026 |  |  |  |  |  |  |  |  |  |  |  |  |  |  |  |
| 15211164 |  | Construct/ Test Gas System (FWD Chambers) |  | 43d | 2012-05-01 | 2012-07-02 | 9-120M FS+141d, 15211070, 15211163a, 15211002b FS-245d | 37d | 17d |  | MECH DES [280 h]; MECH TECH [320 h]; MECH ENG [200 h] | 41,732.4 | CHUDAKOV | 1 | 1 |  | D |  | EUGENE C |  |  |  | 11-006 |  |  | 12-054F |  |  |  |  |  |  |  |  |  |  |  |  |  |  | 11-026 |  |  |  |  |  |  |  |  |  |  |  |  |  |  |  |
| 15211150 |  | Package #1 Final Assy. and Testing (FWD Chambers) |  | 43d | 2012-06-25 | 2012-08-22 | 1546090, 15211249 FS-10d, 15211164 FS-23d, 15211095 FS-80d, 15211145, 15211094 FS-15d, 15211250 FS-10d | 20d | 0d |  | MECH TECH [320 h]; MECH ENG [80 h]; SCIENTIST [160 h]; ELEC TECH [40 h] | 32,893.2 | CHUDAKOV | 1 | 1 |  | D |  | EUGENE C | 09-014 |  |  | 11-006 |  |  | 12-054F |  |  |  |  |  |  |  |  |  |  |  |  |  |  | 11-026 |  |  |  |  |  |  |  |  |  |  |  |  |  |  |  |
| 15211141 |  | Package #4 Fabrication (FWD Chambers) FY12 |  | 55.5d | 2012-07-12 | 2012-09-28 | 15211135 FS-16d | 63d | 0d |  | MECH ENG [270.26 h]; ELEC TECH [154.43 h]; SCIENTIST [154.43 h]; MECH TECH [3281.74 h]; MECH DES [77.22 h] | 186,230.15 | CHUDAKOV | 1 | 1 |  | D |  | EUGENE C | 09-014 | 10-042 |  | 11-006 |  | 12-053 | 12-054F |  |  |  |  |  |  |  |  |  |  |  |  |  |  | 11-026 |  |  |  |  |  |  |  |  |  |  |  |  |  |  |  |
| 15211195 |  | Cell #25 Assy. (FWD Chambers) |  | 22d | 2012-08-03 | 2012-09-05 | 15211135 | 468.5d | 0d |  | MECH TECH [480 h]; MECH ENG [40 h] | 24,136 | CHUDAKOV | 1 | 1 |  | D |  | EUGENE C | 09-014 | 10-042 |  | 11-006 |  |  | 12-054F |  |  |  |  |  |  |  |  |  |  |  |  |  |  | 11-026 |  |  |  |  |  |  |  |  |  |  |  |  |  |  |  |
| 15211155a |  | Package #2 Final Assy. and Testing (FWD Chambers) FY12 |  | 26d | 2012-08-23 | 2012-09-28 | 15211150, 15211155 | 20d | 0d |  | MECH ENG [50.73 h]; MECH TECH [202.93 h]; SCIENTIST [101.46 h]; ELEC TECH [25.37 h] | 20,859.07 | CHUDAKOV | 1 | 1 |  | D |  | EUGENE C |  | 10-042 |  | 11-006 |  | 12-053 | 12-054F |  |  |  |  |  |  |  |  |  |  |  |  |  |  | 11-026 |  |  |  |  |  |  |  |  |  |  |  | 09-012 |  |  |  |
| 15211200 |  | Cell #26 Assy. (FWD Chambers) |  | 20d | 2012-08-24 | 2012-09-24 | 15211195 FS-7d | 468.5d | 131.5d |  | MECH TECH [480 h]; MECH ENG [40 h] | 24,136 | CHUDAKOV | 1 | 1 |  | D |  | EUGENE C | 09-014 | 10-042 |  | 11-006 |  |  | 12-054F |  |  |  |  |  |  |  |  |  |  |  |  |  |  | 11-026 |  |  |  |  |  |  |  |  |  |  |  |  |  |  |  |

Notes:
- 15211000a: Steps: Lab Equipment; Rigid Flex; Machine Shop; Assembly Jig
- 15211000b: Steps: Wire Planes Preparations; Catode Planes Preparations; Package Assembly; Service Infrastructure

| ID | Activity | Duration | Start | Finish | Predecessors | Total float | Free float | Calendar | Resources | Cost | RESP - Responsibility | STRT%COMP for CM EVM | FNSH%COMP for CM EVM | HALL D Related Milestones | CAM RESPONSIBLE | CR 09-014 | CR 10-042 | CR 11-006 | CR 11-026 | CR 12-053 | CR 12-054 | CR 09-012 | CR 13-014 | ReBaseline Actuals Adjustment | Original Activity ID Rebaseline | EVMS Reporting Codes | CR 13-007 | BOE Labor | CR 13-015 | Post Rebaseline | BOE Expenses | Over Under Fixed | Obligated Prior to Rebaseline | CR 14-001 |
| --- | --- | --- | --- | --- | --- | --- | --- | --- | --- | --- | --- | --- | --- | --- | --- | --- | --- | --- | --- | --- | --- | --- | --- | --- | --- | --- | --- | --- | --- | --- | --- | --- | --- | --- |
| 15211141a | Package #4 Fabrication (FWD Chambers) FY13 | 2d | 2012-10-01 | 2012-10-02 | 15211141 | 63d | 43d |  | MECH ENG [9.74 h]; ELEC TECH [5.57 h]; SCIENTIST [5.57 h]; MECH TECH [118.26 h]; MECH DES [2.78 h] | 6,925.87 | CHUDAKOV | 1 | 1 | D | EUGENE C | 09-014 | 10-042 | 11-006 | 11-026 | 12-053 | 12-054F |  |  |  |  |  |  |  |  |  |  |  |  |  |
| 15211155aa | Package #2 Final Assy. and Testing (FWD Chambers) FY13 | 15d | 2012-10-01 | 2012-10-19 | 15211155a | 20d | 0d |  | MECH ENG [29.27 h]; MECH TECH [117.07 h]; SCIENTIST [58.54 h]; ELEC TECH [14.63 h] | 12,418.28 | CHUDAKOV | 1 | 1 | D | EUGENE C |  | 10-042 | 11-006 | 11-026 | 12-053 | 12-054F | 09-012 |  |  |  |  |  |  |  |  |  |  |  |  |
| 15211160 | 3rd Package Final Assy. and Testing (FWD Chambers) | 45d | 2012-10-01 | 2012-12-04 | 15211155aa FS-15d, 15211155 | 20d | 0d |  | MECH ENG [80 h]; MECH TECH [320 h]; SCIENTIST [40 h]; ELEC TECH [40 h] | 25,200 | CHUDAKOV | 1 | 1 | D | EUGENE C |  | 10-042 | 11-006 | 11-026 |  | 12-054F | 09-012 |  |  |  |  |  |  |  |  |  |  |  |  |
| 15211191 | Procurement of Consumables for Fab (2013) (FWD Chambers) | 100d | 2012-10-01 | 2013-03-01 | 15211190 | 71d | 51d |  | PROCUREMENT<$50K 60 | 11,925.96 | CHUDAKOV | 1 | 1 | D | EUGENE C | 09-014 | 10-042 | 11-006 | 11-026 |  | 12-054F |  |  |  |  |  |  |  |  |  |  |  |  |  |
| 15211165 | 4th Package Final Assy. and Testing (FWD Chambers) | 71d | 2012-12-05 | 2013-03-25 | 15211141a, 15211160 | 20d | 0d |  | MECH ENG [40 h]; SCIENTIST [120 h]; MECH TECH [320 h] | 26,312.8 | CHUDAKOV | 1 | 1 | D | EUGENE C |  |  | 11-006 | 11-026 |  | 12-054 |  |  |  |  |  |  |  |  |  |  |  |  |  |
| 15211175 | Complete Package Assy (FWD Chambers) | 47d | 2013-01-31 | 2013-04-08 | 15211165 FS-37d, 15211075a, 15211160, 15211075, 15211060, 15211150, 15211060a, 15211135, 15211145 | 20d | 0d |  | ELEC TECH [40 h]; MECH DES [120 h]; MECH ENG [120 h]; MECH TECH [320 h]; SCIENTIST [80 h] | 36,974 | CHUDAKOV | 1 | 1 | D | EUGENE C | 09-014 | 10-042 | 11-006 | 11-026 |  | 12-054 |  |  |  |  |  |  |  |  |  |  |  |  |  |
| 15211220 | Final Testing (FWD Chambers) | 40d | 2013-02-04 | 2013-04-01 | 15211145, 15211175 FS-45d | 25d | 5d |  | MECH TECH [160 h]; SCIENTIST [160 h] | 18,995.2 | CHUDAKOV | 1 | 1 | D | EUGENE C |  | 10-042 | 11-006 | 11-026 |  | 12-054 | 09-012 |  |  |  |  |  |  |  |  |  |  |  |  |
| 15211230 | Alignment Procedures (FWD Chambers) | 10d | 2013-03-08 | 2013-03-21 | 15211175 FS-22d, 15211002c FS-245d | 32d | 0d |  | ELEC TECH [80 h]; MECH TECH [160 h] | 10,980.8 | CHUDAKOV | 1 | 1 | D | EUGENE C | 09-014 | 10-042 | 11-006 | 11-026 |  | 12-054 |  |  |  |  |  |  |  |  |  |  |  |  |  |
| 15211205 | Cell #27 Assy. (FWD Chambers) | 19.5d | 2013-04-01 | 2013-04-26 | 15211200 FS-7d, 9-130M FS+120d | 337d | 0d |  | MECH ENG [40 h]; MECH TECH [480 h] | 24,907.2 | CHUDAKOV | 1 | 1 | D | EUGENE C | 09-014 | 10-042 | 11-006 | 11-026 | 12-053 | 12-054 |  |  |  |  |  |  |  |  |  |  |  |  |  |
| 15211185 | Fiducialize complete package (FWD Chambers) | 5d | 2013-04-02 | 2013-04-08 | 15211175 FS-5d | 20d | 0d |  | MECH TECH [120 h]; MECH ENG [40 h]; SCIENTIST [200 h] | 22,969.6 | CHUDAKOV | 1 | 1 | D | EUGENE C | 09-014 | 10-042 | 11-006 | 11-026 |  | 12-054 |  |  |  |  |  |  |  |  |  |  |  |  |  |
| 15211210 | Cell #28 Assy. (FWD Chambers) | 24.5d | 2013-04-19 | 2013-05-23 | 15211205 FS-5d | 337d |  |  | MECH TECH [480 h]; MECH ENG [40 h] | 24,907.2 | CHUDAKOV | 1 | 1 | D | EUGENE C | 09-014 | 10-042 | 11-006 | 11-026 |  | 12-054 |  |  |  |  |  |  |  |  |  |  |  |  |  |
| 15211255 | Re-Baseline Actuals Adjustment | 1d | 2013-08-30 | 2013-08-30 | 9-130M FS+227d | 20d |  |  | PROCUREMENT>$50K 69 NO ESCALATION | 756,128.94 | CHUDAKOV | 1 | 1 |  | EUGENE C |  |  |  |  |  |  |  | 13-014 | ADJ |  |  |  |  |  |  |  |  |  |  |
| 25211172 | Resolution_studies_(FWD_Chambers) FY13 | 20d | 2013-09-03 | 2013-09-30 | 9-130M FS+228d | 0d |  | 8/5 M-F w/JLAB Holidays ReBaseline | SCIENTIST [64 h] | 4,663.04 | CHUDAKOV | 1 | 1 | D | EUGENE C | 09-014 | 10-042 | 11-006 | 11-026 |  | 12-054 |  |  |  | 25211172 | S | 13-007 | PE | 13-015 | PR |  |  |  |  |
| 25211175 | Complete Package Mechanical Assy (FWD Chambers) FY13 | 20d | 2013-09-03 | 2013-09-30 | 9-130M FS+228d | 56d | 0d | 8/5 M-F w/JLAB Holidays ReBaseline | MECH ENG [5.33 h]; MECH TECH [16 h]; SCIENTIST [5.33 h] | 1,508.46 | CHUDAKOV | 1 | 1 | D | EUGENE C | 09-014 | 10-042 | 11-006 | 11-026 |  | 12-054 |  |  |  | 25211175 | U | 13-007 | EJ | 13-015 | PR |  |  |  |  |
| 25211191 | Procurement of Consumables for Fab (2013) (FWD Chambers) | 20d | 2013-09-03 | 2013-09-30 | 9-130M FS+228d | 42d |  | 8/5 M-F w/JLAB Holidays ReBaseline | SUPPLIES & MATERIALS | 1,093.6 | CHUDAKOV | 1 | 1 | D | EUGENE C | 09-014 | 10-042 | 11-006 | 11-026 |  | 12-054F |  |  |  | 25211191 | U | 13-007F |  | 13-015 | PR | PE |  |  |  |
| 25211208 | Assemble and Electrical Test of Package R (FDC) | 20d | 2013-09-03 | 2013-09-30 | 9-130M FS+228d | 1d | 0d | 8/5 M-F w/JLAB Holidays ReBaseline | MECH TECH [32 h]; SCIENTIST [16 h] | 2,633.28 | CHUDAKOV | 1 | 1 | D | EUGENE C | 09-014 | 10-042 | 11-006 | 11-026 |  | 12-054 |  |  |  | 25211208 | U | 13-007 | PE | 13-015 | PR |  |  |  |  |
| 25211217 | Cooling system assembly FY13 | 20d | 2013-09-03 | 2013-09-30 | 9-130M FS+228d | 204d | 0d | 8/5 M-F w/JLAB Holidays ReBaseline | MECH ENG [6.98 h]; MECH TECH [34.92 h]; SCIENTIST [3.49 h] | 2,361.43 | CHUDAKOV | 1 | 1 | D | EUGENE C | 09-014 | 10-042 | 11-006 | 11-026 |  | 12-054 |  |  |  | 25211217 | U | 13-007 | EJ | 13-015 | PR |  |  |  |  |
| 25211220 | Final Testing (FWD Chambers) | 20d | 2013-09-03 | 2013-09-30 | 25211175 FS-30d, 25211175a FS-30d | 56d |  | 8/5 M-F w/JLAB Holidays ReBaseline | MECH TECH [14 h]; SCIENTIST [56 h] | 4,722.2 | CHUDAKOV | 1 | 1 | D | EUGENE C |  | 10-042 | 11-006 | 11-026 |  | 12-054 | 09-012 |  |  | 25211220 | U | 13-007 | PE | 13-015 | PR |  |  |  |  |
| 25211250 | Disassembly of the construction equipment and site - labor and forklift lease | 20d | 2013-09-03 | 2013-09-30 | 25211208 FS-20d | 247d |  | 8/5 M-F w/JLAB Holidays ReBaseline | SUPPLIES & MATERIALS; SCIENTIST [10 h]; MECH ENG [10 h]; MECH TECH [80 h] | 5,541 | CHUDAKOV | 1 | 1 | D | EUGENE C | 09-014 | 10-042 | 11-006 | 11-026 |  | 12-054 |  |  |  | 25211250 | U | 13-007 | EJ | 13-015 | PR | EJ |  |  |  |
| 25211255LOE | Pick-up Truck Lease | 139d | 2013-09-03 | 2014-03-31 | 25211208 FS-20d | 128d |  | 8/5 M-F w/JLAB Holidays ReBaseline | PROCUREMENT<$50K 60 NO ESCALATION FY14 | 2,604.93 | CHUDAKOV | 1 | 1 | D | EUGENE C | 09-014 | 10-042 | 11-006 | 11-026 |  | 12-054 |  |  |  | 25211250 | U | 13-007 | EJ | 13-015 | PR | EJ | y | OB |  |
| 25211255LOE5 | Blue Crab Cleaning (Previously Obligated) | 20d | 2013-09-03 | 2013-09-30 | 25211208 FS-20d | 247d |  | 8/5 M-F w/JLAB Holidays ReBaseline | PROCUREMENT<$50K 60 | 153.5 | CHUDAKOV | 1 | 1 | D | EUGENE C | 09-014 | 10-042 | 11-006 | 11-026 |  | 12-054 |  |  |  | 25211250 | U | 13-007 | EJ | 13-015 | PR | EJ | y | OB |  |
| 25211260 | Develop algorithm for fADC125 readout FY13 | 20d | 2013-09-03 | 2013-09-30 | 9-130M FS+228d | 178d | 0d | 8/5 M-F w/JLAB Holidays ReBaseline | SCIENTIST [80.9 h] | 5,894.37 | CHUDAKOV | 1 | 1 | D | EUGENE C | 09-014 | 10-042 | 11-006 | 11-026 |  | 12-054 |  |  |  | 25211260 | S | 13-007 | PE | 13-015 | PR |  |  |  |  |
| 25211172a | Resolution_studies_(FWD_Chambers) FY14 | 10d | 2013-10-01 | 2013-10-14 | 25211172, 9-130M FS+228d | 0d |  | 8/5 M-F w/JLAB Holidays ReBaseline | SCIENTIST [32 h] | 2,405.76 | CHUDAKOV | 1 | 1 | D | EUGENE C | 09-014 | 10-042 | 11-006 | 11-026 |  | 12-054 |  |  |  | 25211172 | S | 13-007 | PE | 13-015 | PR |  |  |  | 14-001 |
| 25211175a | Complete Package Mechanical Assy (FWD Chambers) FY14 | 10d | 2013-10-01 | 2013-10-14 | 25211175, 9-130M FS+228d | 56d | 0d | 8/5 M-F w/JLAB Holidays ReBaseline | MECH ENG [2.67 h]; MECH TECH [8 h]; SCIENTIST [2.67 h] | 777.97 | CHUDAKOV | 1 | 1 | D | EUGENE C | 09-014 | 10-042 | 11-006 | 11-026 |  | 12-054 |  |  |  | 25211175 | U | 13-007 | EJ | 13-015 | PR |  |  |  | 14-001 |
| 25211217a | Cooling system assembly FY14 | 43d | 2013-10-01 | 2013-12-02 | 9-130M FS+228d, 25211217 | 204d |  | 8/5 M-F w/JLAB Holidays ReBaseline | MECH ENG [15.02 h]; MECH TECH [75.08 h]; SCIENTIST [7.51 h] | 5,238.27 | CHUDAKOV | 1 | 1 | D | EUGENE C | 09-014 | 10-042 | 11-006 | 11-026 |  | 12-054 |  |  |  | 25211217 | U | 13-007 | EJ | 13-015 | PR |  |  |  | 14-001 |
| 25211260a | Develop algorithm for fADC125 readout FY14 | 69d | 2013-10-01 | 2014-01-17 | 9-130M FS+228d, 25211260 | 178d |  | 8/5 M-F w/JLAB Holidays ReBaseline | SCIENTIST [279.1 h] | 20,982.74 | CHUDAKOV | 1 | 1 | D | EUGENE C | 09-014 | 10-042 | 11-006 | 11-026 |  | 12-054 |  |  |  | 25211260 | S | 13-007 | PE | 13-015 | PR |  |  |  | 14-001 |

| ID | WBS | Activity | Duration | Start | Finish | Predecessors | Total float | Free float | Calendar | Resources | Cost | RESP - Responsibility | STRT%COMP for CM EVM | FNSH%COMP for CM EVM | HALL D Related Milestones | CR 07-024 | CAM RESPONSIBLE | CR 08-058 | CR 11-006 | CR 11-026 | CR 12-054 | Advance Purchase Plan > 500K | CR 09-012 | CR 10-007 | 12 GeV 2nd level Critical Path | CR 09-014 | CR 09-027 | CR 09-027 Repair | CR 10-042 | CR 11-001 | CR 09-046 | CR 12-055 | CR 10-024 | CR 13-014 | ReBaseline Actuals Adjustment | Original Activity ID Rebaseline | EVMS Reporting Codes | CR 13-007 | BOE Labor | CR 13-015 | Post Rebaseline | CR 14-001 |
| --- | --- | --- | --- | --- | --- | --- | --- | --- | --- | --- | --- | --- | --- | --- | --- | --- | --- | --- | --- | --- | --- | --- | --- | --- | --- | --- | --- | --- | --- | --- | --- | --- | --- | --- | --- | --- | --- | --- | --- | --- | --- | --- |
|  | 2 | **1.5.2.1.2 CENTRAL CHAMBERS** |  | 2009-01-02 | 2014-04-21 |  |  |  |  |  |  |  |  |  |  |  |  |  |  |  |  |  |  |  |  |  |  |  |  |  |  |  |  |  |  |  |  |  |  |  |  |  |
| 15212009E |  | FY09 Travel (CENT CHAMB) | 189d | 2009-01-02 | 2009-09-30 | 15212009EX | 119d | 0d |  | TRAVEL | 982.69 | CHUDAKOV | 1 | 1 | D | 07-024 | EUGENE C | 08-058 | 11-006 | 11-026 | 12-054F |  |  |  |  |  |  |  |  |  |  |  |  |  |  |  |  |  |  |  |  |  |
| 15212005 |  | Proc Straws (CENT CHAMB) | 65d | 2009-01-05 | 2009-04-07 | 12321018M, 9-090M FS+60d | 783d | 0d |  | PROCUREMENT>$50K 69; PROCUREMENT<$50K 60 | 67,083.51 | CHUDAKOV | 1 | 1 | D |  | EUGENE C |  | 11-006 | 11-026 | 12-054F | APP |  |  |  |  |  |  |  |  |  |  |  |  |  |  |  |  |  |  |  |  |
| 15212010 |  | Proc Wire (CENT CHAMB) | 130d | 2009-01-05 | 2009-07-09 | 9-090M FS+60d, 12321018M | 707d | 0d |  | PROCUREMENT<$50K 60 | 21,296.35 | CHUDAKOV | 1 | 1 | D |  | EUGENE C |  | 11-006 | 11-026 | 12-054F | APP | 09-012 |  |  |  |  |  |  |  |  |  |  |  |  |  |  |  |  |  |  |  |
| 15212070 |  | Proc Epoxy (CENT CHAMB) (Frozen by CR10-007) | 130d | 2009-01-05 | 2009-07-09 | 9-090M FS+60d, 12321018M | 306d |  |  | PROCUREMENT<$50K 60 | 5,324.09 | CHUDAKOV | 1 | 1 | D |  | EUGENE C |  |  |  |  | APP |  | 10-007 |  |  |  |  |  |  |  |  |  |  |  |  |  |  |  |  |  |  |
| 15212090 |  | Test Straws (CENT CHAMB) | 11d | 2009-04-08 | 2009-04-22 | 15212005 | 783d | 729d |  | CONTRB UNIV LBR [800 h] |  | CHUDAKOV | 1 | 1 | D |  | EUGENE C |  | 11-006 | 11-026 | 12-054F |  |  | 10-007 |  |  |  |  |  |  |  |  |  |  |  |  |  |  |  |  |  |  |
| 15212000a |  | Prepare Procurements/Fabrication Packages 2009 (CENT CHAMB) | 86d | 2009-06-01 | 2009-09-30 | 9-090M FS+162d | 582d | 0d |  | MECH ENG [160 h]; MECH DES [480 h] | 31,252.8 | CHUDAKOV | 1 | 1 | D | 07-024 | EUGENE C |  | 11-006 | 11-026 | 12-054F |  |  |  | 2 | 09-014 | 09-027 | 09-027 |  |  |  |  |  |  |  |  |  |  |  |  |  |  |
| 15212015 |  | Proc Feedthroughs (CENT CHAMB) | 130d | 2009-06-01 | 2009-12-03 | 9-090M FS+60d, 12321018M, 15212000a FS-86d | 605d | 0d |  | PROCUREMENT<$50K 60 NO ESCALATION FY10; PROCUREMENT>$50K 69 NO ESCALATION FY10 | 108,611.4 | CHUDAKOV | 1 | 1 | D |  | EUGENE C |  | 11-006 | 11-026 | 12-054F | APP |  |  |  |  | 09-027 | 09-027 |  |  |  |  |  |  |  |  |  |  |  |  |  |  |
| 15212020 |  | Proc Crimp pins (CENT CHAMB) | 130d | 2009-06-01 | 2009-12-03 | 12321018M, 9-090M FS+60d, 15212000a FS-86d | 617d | 0d |  | PROCUREMENT>$50K 69 NO ESCALATION FY10 | 15,972.26 | CHUDAKOV | 1 | 1 | D |  | EUGENE C |  | 11-006 | 11-026 | 12-054F | APP |  |  |  |  | 09-027 | 09-027 |  |  |  |  |  |  |  |  |  |  |  |  |  |  |
| 15212040 |  | Proc endplates (CENT CHAMB) | 155d | 2009-06-01 | 2010-01-15 | 9-090M FS+60d, 12321018M, 15212000a FS-86d, 15212000c FS-245d, 15212000d FS-245d | 582d | 0d |  | PROCUREMENT<$50K 60 NO ESCALATION FY10; PROCUREMENT>$50K 69 NO ESCALATION FY10 | 63,889.06 | CHUDAKOV | 1 | 1 | D |  | EUGENE C |  | 11-006 | 11-026 | 12-054F | APP |  |  |  |  | 09-027 | 09-027 |  |  |  |  |  |  |  |  |  |  |  |  |  |  |
| 15212050 |  | Proc Stand-offs (CENT CHAMB) | 85d | 2009-06-01 | 2009-09-29 | 15212000a FS-86d, 9-090M FS+60d, 12321018M | 672d | 618d |  | PROCUREMENT<$50K 60 | 5,324.09 | CHUDAKOV | 1 | 1 | D |  | EUGENE C |  | 11-006 | 11-026 | 12-054F | APP |  | 10-007 |  |  | 09-027 | 09-027 |  |  |  |  |  |  |  |  |  |  |  |  |  |  |
| 15212095 |  | Check Wire Quality (CENT CHAMB) | 22d | 2009-07-10 | 2009-08-10 | 15212010 | 707d | 653d |  | PD UNIV STAFF [680 h] | 34,775.2 | CHUDAKOV | 1 | 1 | D |  | EUGENE C |  | 11-006 | 11-026 | 12-054F |  |  | 10-007 |  |  |  |  |  |  |  |  |  |  |  |  |  |  |  |  |  |  |
| 15212000c |  | Support Parts Fabrication 2010 (CENT CHAMB) | 69d | 2009-10-01 | 2010-01-15 | 9-100M | 672d | 90d |  | MECH ENG [20 h]; MECH DES [40 h] | 3,126.6 | CHUDAKOV | 1 | 1 | D | 07-024 | EUGENE C |  | 11-006 | 11-026 | 12-054F |  |  |  | 2 | 09-014 | 09-027 | 09-027 |  |  |  |  |  |  |  |  |  |  |  |  |  |  |
| 15212010E |  | FY10 Travel (CENT CHAMB) | 248d | 2009-10-01 | 2010-09-30 | 15212009E | 119d | 0d |  | TRAVEL | 1,330.62 | CHUDAKOV | 1 | 1 | D | 07-024 | EUGENE C |  | 11-006 | 11-026 | 12-054F |  |  |  |  |  |  |  |  |  |  |  |  |  |  |  |  |  |  |  |  |  |
| 15212075 |  | Reverse Entry per CR10-007 | 1d | 2009-12-01 | 2009-12-01 | 9-100M FS+41d | 206d |  |  | PROCUREMENT<$50K 60 | -5,324.09 | CHUDAKOV | 1 | 1 | D |  | EUGENE C |  |  |  |  | APP |  | 10-007 |  |  |  |  |  |  |  |  |  |  |  |  |  |  |  |  |  |  |
| 15212100 |  | Check Feedthroughs (CENT CHAMB) | 22d | 2009-12-04 | 2010-01-12 | 15212015 | 605d | 551d |  | CONTRB UNIV LBR [800 h] |  | CHUDAKOV | 1 | 1 | D |  | EUGENE C |  | 11-006 | 11-026 | 12-054F |  |  | 10-007 |  |  |  |  |  |  |  |  |  |  |  |  |  |  |  |  |  |  |
| 15212105 |  | Check Crimp pins (CENT CHAMB) | 11d | 2009-12-04 | 2009-12-18 | 15212020 | 617d | 563d |  | CONTRB UNIV LBR [800 h] |  | CHUDAKOV | 1 | 1 | D |  | EUGENE C |  | 11-006 | 11-026 | 12-054F |  |  | 10-007 |  |  |  |  |  |  |  |  |  |  |  |  |  |  |  |  |  |  |
| 15212025 |  | Proc HV Cables (CENT CHAMB) | 130d | 2010-01-05 | 2010-07-09 | 9-100M FS+60d | 482d | 428d |  | PROCUREMENT<$50K 60 | 12,251.46 | CHUDAKOV | 1 | 1 | D |  | EUGENE C |  | 11-006 | 11-026 | 12-054F | APP | 09-012 | 10-007 |  |  |  |  |  |  |  |  |  |  |  |  |  |  |  |  |  |  |
| 15212035 |  | Proc Gas Connectors (CENT CHAMB) | 65d | 2010-01-05 | 2010-04-07 | 9-100M FS+60d | 546d | 492d |  | PROCUREMENT>$50K 69; PROCUREMENT<$50K 60 | 71,421.04 | CHUDAKOV | 1 | 1 | D |  | EUGENE C |  | 11-006 | 11-026 | 12-054F | APP |  |  |  |  |  |  | 10-042 |  |  |  |  |  |  |  |  |  |  |  |  |  |
| 15212080 |  | Proc First Article Preamps (CENT CHAMB) | 102d | 2010-01-05 | 2010-05-28 | 9-100M FS+60d | 272d | 217d |  | PROCUREMENT<$50K 60 | 6,922.35 | CHUDAKOV | 1 | 1 | D |  | EUGENE C |  | 11-006 | 11-026 | 12-054F | APP |  |  |  |  |  |  | 10-042 |  |  |  |  |  |  |  |  |  |  |  |  |  |
| 15212000d |  | Acceptance Checks/Documentation 2010 (CENT CHAMB) | 20d | 2010-01-19 | 2010-02-16 | 9-100M FS+69d | 652d | 70d |  | MECH ENG [20 h]; MECH DES [80 h] | 4,936.2 | CHUDAKOV | 1 | 1 | D | 07-024 | EUGENE C |  | 11-006 | 11-026 | 12-054F |  |  |  | 2 | 09-014 | 09-027 | 09-027 |  |  |  |  |  |  |  |  |  |  |  |  |  |  |
| 15212110 |  | Check endplates (CENT CHAMB) | 10d | 2010-01-19 | 2010-02-01 | 15212040 | 582d | 0d |  | PD UNIV STAFF [800 h] | 42,216 | CHUDAKOV | 1 | 1 | D |  | EUGENE C |  | 11-006 | 11-026 | 12-054F |  |  |  |  |  | 09-027 | 09-027 |  |  |  |  |  |  |  |  |  |  |  |  |  |  |
| 15212001 |  | FY10 Engineering Support for Assembly Prep (CENT CHAMB) | 113d | 2010-02-02 | 2010-07-13 | 9-100M FS+79d | 349d | 0d |  | MECH DES [40 h]; MECH ENG [40 h] | 4,443.6 | CHUDAKOV | 1 | 1 | D | 07-024 | EUGENE C |  | 11-006 | 11-026 | 12-054F |  |  |  |  |  | 09-027 | 09-027 |  |  |  |  |  |  |  |  |  |  |  |  |  |  |
| 15212120 |  | Clean endplates & Compnts (CENT CHAMB) | 10d | 2010-02-02 | 2010-02-16 | 15212001 FS-113d, 15212110 | 582d | 528d |  | PD UNIV STUDNT [400 h] | 4,008 | CHUDAKOV | 1 | 1 | D |  | EUGENE C |  | 11-006 | 11-026 | 12-054F |  |  | 10-007 |  |  | 09-027 | 09-027 |  |  |  |  |  |  |  |  |  |  |  |  |  |  |
| 15212030 |  | Proc Signal Cables (CENT CHAMB) | 130d | 2010-05-14 | 2010-11-16 | 9-100M FS+151d | 391d | 337d |  | PROCUREMENT<$50K 60 NO ESCALATION FY11 | 33,084.43 | CHUDAKOV | 1 | 1 | D |  | EUGENE C |  | 11-006 | 11-026 | 12-054F | APP |  | 10-007 |  |  |  |  | 10-042 |  |  |  |  |  |  |  |  |  |  |  |  |  |
| 15212002 |  | FY10 Engineering Support for Straw Tube Install (CENT CHAMB) FY10 | 56d | 2010-07-14 | 2010-09-30 | 15212001 | 349d | 0d |  | MECH DES [34.46 h]; MECH ENG [17.23 h] | 2,693.57 | CHUDAKOV | 1 | 1 | D | 07-024 | EUGENE C |  | 11-006 | 11-026 | 12-054F |  |  | 10-007 |  |  | 09-027 | 09-027 |  | 11-001 |  |  |  |  |  |  |  |  |  |  |  |  |
| 15212002a |  | FY10 Engineering Support for Straw Tube Install (CENT CHAMB) FY11 | 74d | 2010-10-01 | 2011-01-25 | 15212002 | 349d | 295d |  | MECH ENG [22.77 h]; MECH DES [45.54 h] | 3,673.03 | CHUDAKOV | 1 | 1 | D | 07-024 | EUGENE C |  | 11-006 | 11-026 | 12-054F |  |  | 10-007 |  |  | 09-027 | 09-027 |  | 11-001 |  |  |  |  |  |  |  |  |  |  |  |  |
| 15212003 |  | FY11 Engineering Support for Assembly Initial (CENT CHAMB) | 59d | 2010-10-01 | 2010-12-31 | 9-110M | 279d | 0d |  | MECH DES [45.39 h]; MECH ENG [5.67 h] | 2,504.09 | CHUDAKOV | 1 | 1 | D | 07-024 | EUGENE C |  | 11-006 | 11-026 | 12-054F |  |  |  |  |  | 09-027 | 09-027 |  |  |  |  |  |  |  |  |  |  |  |  |  |  |
| 15212011E |  | FY11 Travel (CENT CHAMB) | 248d | 2010-10-01 | 2011-09-30 | 15212010E | 119d | 0d |  | TRAVEL | 1,373.07 | CHUDAKOV | 1 | 1 | D | 07-024 | EUGENE C |  | 11-006 | 11-026 | 12-054F |  |  |  |  |  |  |  |  |  |  |  |  |  |  |  |  |  |  |  |  |  |
| 15212003a |  | FY11 Engineering Support for Assembly Final (CENT CHAMB) | 189d | 2011-01-04 | 2011-09-30 | 15212003 | 279d | 225d |  | MECH DES [680 h]; MECH ENG [160 h]; SCIENTIST [120 h] | 50,826 | CHUDAKOV | 1 | 1 | D | 07-024 | EUGENE C |  | 11-006 | 11-026 | 12-054F |  |  |  |  |  | 09-027 | 09-027 |  |  |  |  |  |  |  |  |  |  |  |  |  |  |
| 15212060 |  | Proc Fiber Glass shell (inner surface) (CENT CHAMB) | 130d | 2011-01-05 | 2011-07-11 | 9-110M FS+60d | 254d | 200d |  | PROCUREMENT<$50K 60 | 566.92 | CHUDAKOV | 1 | 1 | D |  | EUGENE C |  | 11-006 | 11-026 | 12-054F | APP |  |  |  |  |  |  |  |  |  |  |  |  |  |  |  |  |  |  |  |  |
| 15212065 |  | Proc Lucite and hardware (Gas plenum) (CENT CHAMB) | 108d | 2011-03-01 | 2011-08-01 | 9-110M FS+97d | 391d | 219d |  | PROCUREMENT<$50K 60 | 19,900 | CHUDAKOV | 1 | 1 | D |  | EUGENE C |  | 11-006 | 11-026 | 12-054F | APP |  | 10-007 |  |  |  |  |  |  |  |  |  |  |  |  |  |  |  |  |  |  |
| 15212088 |  | Proc Rail Bearings (CENT CHAMB) | 66d | 2011-03-01 | 2011-06-01 | 9-110M FS+97d | 386d | 261d |  | PROCUREMENT<$50K 60 | 2,267.68 | CHUDAKOV | 1 | 1 | D |  | EUGENE C |  | 11-006 | 11-026 | 12-054F | APP |  | 10-007 |  |  |  |  |  |  |  |  |  |  |  |  |  |  |  |  |  |  |
| 15212055 |  | Proc Aluminum shell (Outer surface) (CENT CHAMB) | 86d | 2011-06-01 | 2011-09-30 | 9-110M FS+162d | 196d | 142d |  | PROCUREMENT<$50K 60 | 3,401.5 | CHUDAKOV | 1 | 1 | D |  | EUGENE C |  | 11-006 | 11-026 | 12-054F | APP |  |  |  |  |  |  |  |  |  |  |  |  |  |  |  |  |  |  |  |  |
| 15212045 |  | Prepare Procurement Packages for Supprt Frame (CENT CHAMB) | 44d | 2011-08-01 | 2011-09-30 | 12321018M, 15212000a FS-86d, 9-120M FS-44d | 303d | 0d |  | MECH DES [320 h]; MECH ENG [160 h] | 25,809.6 | CHUDAKOV | 1 | 1 | D |  | EUGENE C |  | 11-006 | 11-026 | 12-054F | APP |  |  |  |  | 09-027 | 09-027 | 10-042 |  | 09-046 |  |  |  |  |  |  |  |  |  |  |  |
| 15212004 |  | FY12 Engineering Support for Assembly (CENT CHAMB) | 247d | 2011-10-03 | 2012-09-28 | 9-120M | 85d | 0d |  | SCIENTIST [120 h]; MECH ENG [160 h]; MECH DES [480 h] | 42,814 | CHUDAKOV | 1 | 1 | D | 07-024 | EUGENE C |  | 11-006 | 11-026 | 12-054F |  |  |  |  |  | 09-027 | 09-027 |  |  |  |  |  |  |  |  |  |  |  |  |  |  |
| 15212012E |  | FY12 Travel (CENT CHAMB) | 247d | 2011-10-03 | 2012-09-28 | 15212011E | 119d | 0d |  | TRAVEL | 1,418.05 | CHUDAKOV | 1 | 1 | D | 07-024 | EUGENE C |  | 11-006 | 11-026 | 12-054F |  |  |  |  |  |  |  |  |  |  |  |  |  |  |  |  |  |  |  |  |  |
| 15212047 |  | Proc Supprt Frame (CENT CHAMB) Part A | 87d | 2011-10-03 | 2012-02-13 | 15212045 | 303d | 249d |  | PROCUREMENT<$50K 60 | 24,876 | CHUDAKOV | 1 | 1 | D |  | EUGENE C |  | 11-006 | 11-026 | 12-054F | APP |  |  |  |  | 09-027 | 09-027 | 10-042 |  | 09-046 | 12-055 |  |  |  |  |  |  |  |  |  |  |
| 15212047a |  | Proc Supprt Frame (CENT CHAMB) Part B | 87d | 2011-10-03 | 2012-02-13 | 15212045 | 303d | 249d |  | PROCUREMENT<$50K 60 | 16,400 | CHUDAKOV | 1 | 1 | D |  | EUGENE C |  | 11-006 | 11-026 | 12-054F | APP |  |  |  |  | 09-027 | 09-027 | 10-042 |  | 09-046 | 12-055 |  |  |  |  |  |  |  |  |  |  |
| 15212115 |  | Test On-Chamb Electrnc's (CENT CHAMB) | 45d | 2012-01-30 | 2012-04-02 | 1546180, 15212080 FS+193d | 55d | 1d |  | PD UNIV STUDNT [192 h]; SCIENTIST [160 h]; CONTRB UNIV LBR [280 h] | 13,346.24 | CHUDAKOV | 1 | 1 | D |  | EUGENE C |  | 11-006 | 11-026 | 12-054F |  |  | 10-007 |  |  | 09-027 | 09-027 | 10-042 |  |  |  | 10-024 |  |  |  |  |  |  |  |  |  |
| 15212145 |  | Gas Sys Installtn (CENT CHAMB) | 1d | 2012-04-03 | 2012-04-03 | 9-120M FS+121d, 15212095, 15212100, 15212050, 15212003a FS-104d, 15212035, 15212002a, 15212120, 15212090 | 54d | 0d |  |  |  | CHUDAKOV | 1 | 1 | D |  | EUGENE C |  | 11-006 | 11-026 | 12-054F |  |  | 10-007 |  |  | 09-027 | 09-027 |  |  |  |  |  |  |  |  |  |  |  |  |  |  |
| 15212155 |  | Mount Signal Connectors (CENT CHAMB) | 20d | 2012-04-04 | 2012-05-01 | 15212105, 15212030, 15212004a FS-299d, 15212115, 15212025, 15212145 | 54d | 0d |  | PD UNIV STUDNT [400 h] | 4,268 | CHUDAKOV | 1 | 1 | D |  | EUGENE C |  | 11-006 | 11-026 | 12-054F |  |  | 10-007 |  |  | 09-027 | 09-027 |  |  |  |  |  |  |  |  |  |  |  |  |  |  |
| 15212160 |  | Attach shell (CENT CHAMB) | 10d | 2012-05-02 | 2012-05-15 | 15212055, 15212004a FS-390d, 15212155, 15212060 | 54d | 0d |  | CONTRB UNIV LBR [800 h] |  | CHUDAKOV | 1 | 1 | D |  | EUGENE C |  | 11-006 | 11-026 | 12-054F |  |  | 10-007 |  |  | 09-027 | 09-027 |  |  |  |  |  |  |  |  |  |  |  |  |  |  |
| 15212087 |  | Alignment CC (CENT CHAMB) | 20d | 2012-06-21 | 2012-07-18 | 9-120M FS+176d, 15212088, 15212160, 15212065 | 172d | 118d |  | PROCUREMENT<$50K 60 | 7,020.05 | CHUDAKOV | 1 | 1 | D |  | EUGENE C |  | 11-006 | 11-026 | 12-054F | APP |  | 10-007 |  |  |  |  |  |  |  |  |  |  |  |  |  |  |  |  |  |  |
| 15212004a |  | FY13 Engineering Support for Assembly (CENT CHAMB) | 143d | 2012-10-01 | 2013-05-01 | 15212004 | 85d | 31d |  | MECH DES [240 h]; SCIENTIST [120 h]; MECH ENG [160 h] | 32,251.2 | CHUDAKOV | 1 | 1 | D | 07-024 | EUGENE C |  | 11-006 | 11-026 | 12-054F |  |  |  |  |  | 09-027 | 09-027 |  |  |  |  |  |  |  |  |  |  |  |  |  |  |
| 15212013E |  | FY13 Travel (CENT CHAMB) | 59d | 2012-10-01 | 2012-12-31 | 15212012E | 119d | 65d |  | TRAVEL | 307.87 | CHUDAKOV | 1 | 1 | D | 07-024 | EUGENE C |  | 11-006 | 11-026 | 12-054F |  |  |  |  |  |  |  |  |  |  |  |  |  |  |  |  |  |  |  |  |  |
| 15212185 |  | Resolution Studies (CENT CHAMB) | 45d | 2012-10-01 | 2012-12-04 | 15212160 FS+95d, 15212088 | 54d | 0d |  | SCIENTIST [475.2 h]; CONTRB UNIV LBR [800 h] | 34,623.07 | CHUDAKOV | 1 | 1 | D |  | EUGENE C |  | 11-006 | 11-026 | 12-054F |  |  | 10-007 |  |  |  |  |  |  |  |  |  |  |  |  |  |  |  |  |  |  |
| 15212190 |  | Cross talk Studies (CENT CHAMB) | 22d | 2012-12-05 | 2013-01-11 | 15212185 | 54d | 0d |  | CONTRB UNIV LBR [1600 h] |  | CHUDAKOV | 1 | 1 | D |  | EUGENE C |  | 11-006 | 11-026 | 12-054F |  |  |  |  |  |  |  |  |  |  |  |  |  |  |  |  |  |  |  |  |  |
| 15212195 |  | Magnetic Field Tests (CENT CHAMB) | 22d | 2013-01-14 | 2013-02-13 | 15212087, 15212190 | 54d | 0d |  | CONTRB UNIV LBR [1600 h] |  | CHUDAKOV | 1 | 1 | D |  | EUGENE C |  | 11-006 | 11-026 | 12-054F |  |  |  |  |  |  |  |  |  |  |  |  |  |  |  |  |  |  |  |  |  |
| 15212200 |  | Shipping (CENT CHAMB) | 35d | 2013-02-14 | 2013-04-04 | 15212047, 15212047a, 15212195 | 54d | 0d |  | PROCUREMENT<$50K 60; CONTRB UNIV LBR [1600 h] | 6,229.81 | CHUDAKOV | 1 | 1 | D |  | EUGENE C |  | 11-006 | 11-026 | 12-054F | APP |  |  |  |  |  |  |  |  | 09-046 |  |  |  |  |  |  |  |  |  |  |  |
| 15212205 |  | Re-Baseline Actuals Adjustment | 1d | 2013-08-30 | 2013-08-30 | 9-130M FS+227d | 20d |  |  | PROCUREMENT>$50K 69 NO ESCALATION | -124,038.9 | CHUDAKOV | 1 | 1 |  |  | EUGENE C |  |  |  |  |  |  |  |  |  |  |  |  |  |  |  |  | 13-014 | ADJ |  |  |  |  |  |  |  |
| 25212185 |  | Resolution Studies (CENT CHAMB) FY13 | 20d | 2013-09-03 | 2013-09-30 | 9-130M FS+228d | 216d | 0d | 8/5 M-F w/JLAB Holidays ReBaseline | SCIENTIST [10.39 h]; CONTRB UNIV LBR [103.9 h] | 757.02 | CHUDAKOV | 1 | 1 | D |  | EUGENE C |  | 11-006 | 11-026 | 12-054F |  |  | 10-007 |  |  |  |  |  |  |  |  |  |  |  | 25212185 | S | 13-007F | PE | 13-015 | PR |  |
| 25212185a |  | Resolution Studies (CENT CHAMB) FY14 | 134d | 2013-10-01 | 2014-04-21 | 9-130M FS+228d, 25212185 | 216d |  | 8/5 M-F w/JLAB Holidays ReBaseline | SCIENTIST [69.61 h]; CONTRB UNIV LBR [696.1 h] | 5,233.28 | CHUDAKOV | 1 | 1 | D |  | EUGENE C |  | 11-006 | 11-026 | 12-054F |  |  | 10-007 |  |  |  |  |  |  |  |  |  |  |  | 25212185 | S | 13-007F | PE | 13-015 | PR | 14-001 |
| 25212010 |  | Prepare as built drawings for CDC (CENT CHAMB) | 33d | 2013-10-31 | 2013-12-18 | 2561110 FS-20d | 192d |  | 8/5 M-F w/JLAB Holidays ReBaseline | SCIENTIST [40 h]; MECH DES [200 h]; MECH ENG [24 h] | 15,059.28 | CHUDAKOV | 1 | 1 | D | 07-024 | EUGENE C |  | 11-006 | 11-026 | 12-054F |  |  |  |  |  | 09-027 | 09-027 |  |  |  |  |  |  |  | 25212010 | S | 13-007F | PE | 13-015 | PR | 14-001 |

| ID | WBS | Activity | Duration | Start | Finish | Predecessors | Total float | Free float | Calendar | Resources | Cost | RESP - Responsibility | STRT%COMP for CM EVM | FNSH%COMP for CM EVM | 12 GeV 2nd level Critical Path | HALL D Related Milestones | CR 07-024 | CAM RESPONSIBLE | CR 09-014 | CR 09-027 | CR 09-027 Repair | CR 11-006 | CR 11-026 | CR 12-021 | CR 12-054 | CR 12-053 | CR 12-034 | CR 12-055 | CR 08-016 | CR 13-014 | ReBaseline Actuals Adjustment | Original Activity ID Rebaseline | Over Under Fixed | EVMS Reporting Codes | CR 13-007 | BOE Procurement | CR 13-015 | Post Rebaseline | Obligated Prior to Rebaseline | BOE Labor | CR 14-001 | BOE Expenses | 12 GeV 1st level Critical Path | CIVIL CRITICAL MILESTONES | 12 GeV 5th level Critical Path | Advance Purchase Plan > 500K | CR 09-004 | 12 GEV MAJOR PROCUREMENT CATAGORY | CR 08-058 | CR 09-043 | CR 09-012 | CR 09-052 | CR 10-001 | CR 10-024 | CR 10-002 |
| --- | --- | --- | --- | --- | --- | --- | --- | --- | --- | --- | --- | --- | --- | --- | --- | --- | --- | --- | --- | --- | --- | --- | --- | --- | --- | --- | --- | --- | --- | --- | --- | --- | --- | --- | --- | --- | --- | --- | --- | --- | --- | --- | --- | --- | --- | --- | --- | --- | --- | --- | --- | --- | --- | --- | --- |
|  | 3 | **1.5.2.1.3 START COUNTERS** |  | 2011-12-01 | 2014-02-27 |  |  |  |  |  |  |  |  |  |  |  |  |  |  |  |  |  |  |  |  |  |  |  |  |  |  |  |  |  |  |  |  |  |  |  |  |  |  |  |  |  |  |  |  |  |  |  |  |  |  |
| 15213000 |  | Prepare Fabrication Packages (START COUNTERS) | 80d | 2011-12-01 | 2012-04-02 | 9-120M FS+41d | 189d | 0d |  | MECH ENG [40 h]; MECH DES [400 h] | 22,072.8 | CHUDAKOV | 1 | 1 | 2 | D | 07-024 | EUGENE C | 09-014 | 09-027 | 09-027 | 11-006 | 11-026 | 12-021F | 12-054F |  |  |  |  |  |  |  |  |  |  |  |  |  |  |  |  |  |  |  |  |  |  |  |  |  |  |  |  |  |  |
| 15213001 |  | FY12 Engineering Support for Assembly (START COUNTERS) FY12 | 126d | 2012-04-03 | 2012-09-28 | 15213000, 9-120M | 189d | 0d |  | MECH ENG [54.49 h]; MECH DES [81.73 h] | 7,757.77 | CHUDAKOV | 1 | 1 | 2 | D | 07-024 | EUGENE C | 09-014 | 09-027 | 09-027 | 11-006 | 11-026 | 12-021 | 12-054F | 12-053 |  |  |  |  |  |  |  |  |  |  |  |  |  |  |  |  |  |  |  |  |  |  |  |  |  |  |  |  |  |
| 15213001a |  | FY12 Engineering Support for Assembly (START COUNTERS) FY13 | 59d | 2012-10-01 | 2012-12-31 | 15213001 | 189d |  |  | MECH DES [38.27 h]; MECH ENG [25.51 h] | 3,748.3 | CHUDAKOV | 1 | 1 | 2 | D | 07-024 | EUGENE C | 09-014 | 09-027 | 09-027 | 11-006 | 11-026 | 12-021 | 12-054F | 12-053 |  |  |  |  |  |  |  |  |  |  |  |  |  |  |  |  |  |  |  |  |  |  |  |  |  |  |  |  |  |
| 15213010 |  | Procure Sipms Part A | 184d | 2012-10-01 | 2013-06-28 | 9-130M | 64d |  |  | PROCUREMENT<$50K 60 | 9,906.24 | CHUDAKOV | 1 | 1 |  | D |  | EUGENE C |  |  |  |  |  | 12-021 | 12-054F |  | 12-034 | 12-055 |  |  |  |  |  |  |  |  |  |  |  |  |  |  |  |  |  |  |  |  |  |  |  |  |  |  |  |
| 15213010a |  | Procure Sipms Part B | 184d | 2012-10-01 | 2013-06-28 | 9-130M | 64d |  |  | PROCUREMENT<$50K 60 | 21,050.76 | CHUDAKOV | 1 | 1 |  | D |  | EUGENE C |  |  |  |  |  | 12-021 | 12-054F |  | 12-034 | 12-055 |  |  |  |  |  |  |  |  |  |  |  |  |  |  |  |  |  |  |  |  |  |  |  |  |  |  |  |
| 15213005 |  | Fabricate Start Counter (START COUNTERS) | 65d | 2013-05-31 | 2013-08-30 | 9-130M FS+163d, 15213000 | 20d |  |  | CONTRB UNIV LBR [3245.39 h]; PROCUREMENT<$50K 60 NO ESCALATION FY14 |  | CHUDAKOV | 1 | 1 |  | D |  | EUGENE C | 09-014 |  |  | 11-006 | 11-026 | 12-021 | 12-054 |  | 12-034 |  | 08-016 | 13-014 |  |  |  |  |  |  |  |  |  |  |  |  |  |  |  |  |  |  |  |  |  |  |  |  |  |
| 15213015 |  | Re-Baseline Actuals Adjustment | 1d | 2013-08-30 | 2013-08-30 | 9-130M FS+227d | 20d |  |  | PROCUREMENT>$50K 69 NO ESCALATION | -1,125.31 | CHUDAKOV | 1 | 1 |  |  |  | EUGENE C |  |  |  |  |  |  |  |  |  |  |  | 13-014 | ADJ |  |  |  |  |  |  |  |  |  |  |  |  |  |  |  |  |  |  |  |  |  |  |  |  |
| 25213005 |  | Fabricate (FIU) Start Counter (START COUNTERS) | 117d | 2013-09-03 | 2014-02-27 | 9-130M FS+228d | 131d | 120d | 8/5 M-F w/JLAB Holidays ReBaseline | PROCUREMENT<$50K 60 NO ESCALATION FY14 | 28,432.65 | CHUDAKOV | 1 | 1 |  | D |  | EUGENE C | 09-014 |  |  | 11-006 | 11-026 | 12-021 | 12-054 |  | 12-034 |  | 08-016 |  |  | 25213005 | y | D | 13-007F | VQ | 13-015 | PR | OB |  |  |  |  |  |  |  |  |  |  |  |  |  |  |  |  |
| 25213015 |  | All Manufacturing Drawings for start counter FY13 | 20d | 2013-09-03 | 2013-09-30 | 9-130M FS+228d | 154d | 0d | 8/5 M-F w/JLAB Holidays ReBaseline | MECH DES [27.78 h]; MECH ENG [2.78 h] | 1,582.06 | CHUDAKOV | 1 | 1 | 2 | D |  | EUGENE C |  |  |  |  |  |  |  |  |  |  |  |  |  | 25213015 |  | S | 13-007 |  | 13-015 | PR |  | PE |  |  |  |  |  |  |  |  |  |  |  |  |  |  |  |
| 25213015a |  | All Manufacturing Drawings for start counter FY14 | 16d | 2013-10-01 | 2013-10-22 | 9-130M FS+228d, 25213015 | 154d | 0d | 8/5 M-F w/JLAB Holidays ReBaseline | MECH DES [22.22 h]; MECH ENG [2.22 h] | 1,305.69 | CHUDAKOV | 1 | 1 | 2 | D |  | EUGENE C |  |  |  |  |  |  |  |  |  |  |  |  |  | 25213015 |  | S | 13-007 |  | 13-015 | PR |  | PE | 14-001 |  |  |  |  |  |  |  |  |  |  |  |  |  |  |
| 25213020 |  | Procure start counter support frame parts | 67d | 2013-10-23 | 2014-02-07 | 25213015, 25213015a | 154d | 0d | 8/5 M-F w/JLAB Holidays ReBaseline | PROCUREMENT<$50K 60; SUPPLIES & MATERIALS | 5,262.69 | CHUDAKOV | 1 | 1 | 2 | D |  | EUGENE C |  |  |  |  |  |  |  |  |  |  |  |  |  | 25213020 |  | D | 13-007 |  | 13-015 | PR |  |  | 14-001 | EJ |  |  |  |  |  |  |  |  |  |  |  |  |  |
| 25213025 |  | Assemble start counter support frame | 25d | 2014-01-03 | 2014-02-07 | 25213020 FS-25d | 154d | 143d | 8/5 M-F w/JLAB Holidays ReBaseline | MECH TECH [160 h]; MECH ENG [40 h] | 10,558 | CHUDAKOV | 1 | 1 | 2 | D |  | EUGENE C |  |  |  |  |  |  |  |  |  |  |  |  |  | 25213025 |  | S | 13-007 |  | 13-015 | PR |  | PE | 14-001 |  |  |  |  |  |  |  |  |  |  |  |  |  |  |
|  | 2 | **1.5.2.2 CALORIMETRY** |  | 2008-12-01 | 2014-01-16 |  |  |  |  |  |  |  |  |  |  |  |  |  |  |  |  |  |  |  |  |  |  |  |  |  |  |  |  |  |  |  |  |  |  |  |  |  |  |  |  |  |  |  |  |  |  |  |  |  |  |
|  | 1 | **1.5.2.2.1 BARREL CALORIMETER** |  | 2008-12-01 | 2013-11-27 |  |  |  |  |  |  |  |  |  |  |  |  |  |  |  |  |  |  |  |  |  |  |  |  |  |  |  |  |  |  |  |  |  |  |  |  |  |  |  |  |  |  |  |  |  |  |  |  |  |  |
| 15221010 |  | Proc SciFi Mods 01-06 (BarCal) P-1 | 121d | 2008-12-01 | 2009-05-29 | 9-090M FS+41d, 123221025, 12322018M, 1-6M | 220d | 0d |  | PROCUREMENT>$50K 69; PROCUREMENT<$50K 60 | 415,776 | CHUDAKOV | 1 | 1 |  | D | 07-024 | EUGENE C |  |  |  | 11-006 | 11-026 | 12-021F | 12-054F |  |  |  |  |  |  |  |  |  |  |  |  |  |  |  |  |  | 1 | CVL | 5 | APP | 09-004 | 5221A |  |  |  |  |  |  |  |
| 15221009E |  | FY09 Travel (BarCal) | 189d | 2009-01-02 | 2009-09-30 | 15221009EX | 496d | 0d |  | TRAVEL | 5,625.95 | CHUDAKOV | 1 | 1 |  | D | 07-024 | EUGENE C |  |  |  | 11-006 | 11-026 |  |  |  |  |  |  |  |  |  |  |  |  |  |  |  |  |  |  |  |  |  |  |  |  |  | 08-058 |  |  |  |  |  |  |
| 15221060 |  | Proc Lead Sheets 1-6 (BarCal) | 60d | 2009-01-05 | 2009-03-31 | 9-090M FS+60d, 12322018M | 424d | 0d |  | PROCUREMENT<$50K 60 | 24,490.81 | CHUDAKOV | 1 | 1 |  | D |  | EUGENE C |  |  |  | 11-006 | 11-026 | 12-021F | 12-054F |  |  |  |  |  |  |  |  |  |  |  |  |  |  |  |  |  |  |  |  |  |  |  |  |  |  |  |  |  |  |
| 15221035 |  | Proc Clean Room (BarCal) | 60d | 2009-04-01 | 2009-06-24 | 9-090M FS+120d | 741d | 46d |  | PROCUREMENT<$50K 60; PD UNIV STUDNT [320 h] | 35,051.73 | CHUDAKOV | 1 | 1 |  | D |  | EUGENE C | 09-014 |  |  | 11-006 | 11-026 | 12-021F | 12-054F |  |  |  |  |  |  |  |  |  |  |  |  |  |  |  |  |  |  |  |  | APP |  | 5221B |  | 09-043 |  |  |  |  |  |
| 15221040 |  | Proc Fiber Handling & Sorting table (BarCal) | 60d | 2009-04-01 | 2009-06-24 | 9-090M FS+120d | 741d | 46d |  | PROCUREMENT<$50K 60; PD UNIV STUDNT [160 h] | 4,748.05 | CHUDAKOV | 1 | 1 |  | D |  | EUGENE C | 09-014 |  |  | 11-006 | 11-026 | 12-021F | 12-054F |  |  |  |  |  |  |  |  |  |  |  |  |  |  |  |  |  |  |  |  |  |  |  |  | 09-043 |  |  |  |  |  |
| 15221045 |  | Proc 2nd Swaging machine (BarCal) | 60d | 2009-04-01 | 2009-06-24 | 9-090M FS+120d | 695d | 46d |  | PROCUREMENT<$50K 60 | 26,620.44 | CHUDAKOV | 1 | 1 |  | D |  | EUGENE C | 09-014 |  |  | 11-006 | 11-026 | 12-021F | 12-054F |  |  |  |  |  |  |  |  |  |  |  |  |  |  |  |  |  |  |  |  | APP |  | 5221B |  | 09-043 |  |  |  |  |  |
| 15221070 |  | Proc Lead Sheets 25-30 (BarCal) | 60d | 2009-04-01 | 2009-06-24 | 15221060 | 424d | 0d |  | PROCUREMENT<$50K 60 | 24,490.81 | CHUDAKOV | 1 | 1 |  | D |  | EUGENE C |  |  |  | 11-006 | 11-026 | 12-021F | 12-054F |  |  |  |  |  |  |  |  |  |  |  |  |  |  |  |  |  |  |  |  |  |  |  |  |  |  |  |  |  |  |
| 15221190 |  | Lead Cutting & Swaging Mods 1-6 (BarCal) (FROZEN and Reversed BY CR09-043 Activity 15221191) | 60d | 2009-04-01 | 2009-06-24 | 9-090M FS+120d | 68d |  |  | PD UNIV STUDNT [1440 h] | 13,982.4 | CHUDAKOV | 1 | 1 |  | D |  | EUGENE C | 09-014 |  |  |  |  |  |  |  |  |  |  |  |  |  |  |  |  |  |  |  |  |  |  |  |  |  |  |  |  |  |  | 09-043 |  |  |  |  |  |
| 15221192LOE |  | Bcal Module Construction Manager Initial Prototype | 106d | 2009-04-01 | 2009-08-28 | 9-090M FS+120d | 84d | 0d |  | PD UNIV STAFF [571.8 h] | 29,241.85 | CHUDAKOV | 1 | 1 |  | D |  | EUGENE C | 09-014 |  |  | 11-006 | 11-026 | 12-021F | 12-054F |  |  |  |  |  |  |  |  |  |  |  |  |  |  |  |  |  |  |  |  | APP |  | 5221B |  | 09-043 |  |  |  |  |  |
| 15221012 |  | Proc SciFi Mods 25-30 (BarCal) P-2 | 86d | 2009-06-01 | 2009-09-30 | 9-090M, 15221010 | 220d | 0d |  | PROCUREMENT>$50K 69; PROCUREMENT<$50K 60 | 417,480 | CHUDAKOV | 1 | 1 |  | D | 07-024 | EUGENE C |  |  |  | 11-006 | 11-026 | 12-021F | 12-054F |  |  |  | 08-016 |  |  |  |  |  |  |  |  |  |  |  |  |  | 1 | CVL | 5 | APP | 09-004 | 5221A |  |  | 09-012 | 09-052 |  |  |  |
| 15221001 |  | Prepare Fabrication Packages 2009 (BarCal) | 45d | 2009-06-02 | 2009-08-04 | 9-090M FS+163d | 695d | 0d |  | MECH ENG [80 h]; MECH DES [240 h] | 15,626.4 | CHUDAKOV | 1 | 1 | 2 | D | 07-024 | EUGENE C | 09-014 | 09-027 | 09-027 | 11-006 | 11-026 | 12-021F | 12-054F |  |  |  |  |  |  |  |  |  |  |  |  |  |  |  |  |  |  |  |  |  |  |  |  |  |  |  |  |  |  |
| 15221080 |  | Proc Lead Sheets 7-12 (BarCal) | 60d | 2009-06-25 | 2009-09-18 | 15221070 | 424d | 0d |  | PROCUREMENT<$50K 60 | 24,490.81 | CHUDAKOV | 1 | 1 |  | D |  | EUGENE C |  |  |  | 11-006 | 11-026 | 12-021F | 12-054F |  |  |  |  |  |  |  |  |  |  |  |  |  |  |  |  |  |  |  |  |  |  |  |  |  |  |  |  |  |  |
| 15221185 |  | Scifi Sorting & Bundling Mods 1-6 (BarCal) (FROZEN and Reversed BY CR09-043 Activity 15221191) | 26d | 2009-06-25 | 2009-07-31 | 9-090M FS+180d | 42d |  |  | PD UNIV STUDNT [34.67 h] | 336.65 | CHUDAKOV | 1 | 1 |  | D |  | EUGENE C | 09-014 |  |  |  |  |  |  |  |  |  |  |  |  |  |  |  |  |  |  |  |  |  |  |  |  |  |  |  |  |  |  | 09-043 |  |  |  |  |  |
| 15221310 |  | Lead Cutting & Swaging Mods 25-30 (BarCal) (FROZEN and Reversed BY CR09-043 Activity 15221191) | 26d | 2009-06-25 | 2009-07-31 | 9-090M FS+180d | 42d |  |  | PD UNIV STUDNT [624 h] | 6,059.04 | CHUDAKOV | 1 | 1 |  | D |  | EUGENE C | 09-014 |  |  |  |  |  |  |  |  |  |  |  |  |  |  |  |  |  |  |  |  |  |  |  |  |  |  |  |  |  |  | 09-043 |  |  |  |  |  |
| 15221002 |  | Evaluate Procurements 2009 (BarCal) | 65d | 2009-06-30 | 2009-09-30 | 15221001 FS-25d | 695d | 0d |  | MECH ENG [80 h] | 5,104.8 | CHUDAKOV | 1 | 1 | 2 | D | 07-024 | EUGENE C | 09-014 | 09-027 | 09-027 | 11-006 | 11-026 | 12-021F | 12-054F |  |  |  |  |  |  |  |  |  |  |  |  |  |  |  |  |  |  |  |  |  |  |  |  | 09-043 |  |  |  |  |  |
| 15221191 |  | Reverse Entry for Frozen Activities 15221185, 15221190 and 15221310 Per CR09-043 | 1d | 2009-08-05 | 2009-08-05 | 9-090M FS+208d | 39d |  |  | PD UNIV STUDNT [-2098.8 h] | -20,379.35 | CHUDAKOV | 1 | 1 |  | D |  | EUGENE C | 09-014 |  |  |  |  |  |  |  |  |  |  |  |  |  |  |  |  |  |  |  |  |  |  |  |  |  |  |  |  |  |  | 09-043 |  |  |  |  |  |
| 15221050 |  | Proc 2nd press/Frame (BarCal) | 120d | 2009-08-31 | 2010-03-01 | 9-090M FS+226d | 595d | 0d |  | PROCUREMENT<$50K 60 NO ESCALATION | 30,655 | CHUDAKOV | 1 | 1 |  | D |  | EUGENE C | 09-014 |  |  | 11-006 | 11-026 | 12-021F | 12-054F |  |  |  |  |  |  |  |  |  |  |  |  |  |  |  |  |  |  |  |  | APP |  | 5221B |  | 09-043 |  |  | 10-001A |  |  |
| 15221195 |  | Bcal Module Construction Manager Phase 1 (LOE) | 120d | 2009-08-31 | 2010-03-01 | 15221192LOE | 84d | 0d |  | PROCUREMENT<$50K 60 NO ESCALATION; PROCUREMENT>$50K 69 NO ESCALATION | 50,160 | CHUDAKOV | 1 | 1 |  | D |  | EUGENE C |  |  |  | 11-006 | 11-026 | 12-021F | 12-054F |  |  |  |  |  |  |  |  |  |  |  |  |  |  |  |  |  |  |  |  | APP |  | 5221B |  | 09-043 |  |  | 10-001A |  |  |
| 15221200 |  | Module #1 Matrix Fabrication | 64d | 2009-08-31 | 2009-12-01 | 15221002 FS-22d, 15221035, 15221040, 9-090M FS+226d | 695d | 611d |  | PROCUREMENT>$50K 69 NO ESCALATION | 12,842 | CHUDAKOV | 1 | 1 |  | D |  | EUGENE C |  |  |  | 11-006 | 11-026 | 12-021F | 12-054F |  |  |  | 08-016 |  |  |  |  |  |  |  |  |  |  |  |  |  |  |  |  | APP |  | 5221B |  | 09-043 |  |  | 10-001A |  |  |
| 15221205 |  | Module #1 Machining and Shipping | 108d | 2009-08-31 | 2010-02-10 | 9-090M FS+226d | 646d | 0d |  | PROCUREMENT>$50K 69 NO ESCALATION | 4,607 | CHUDAKOV | 1 | 1 |  | D |  | EUGENE C |  |  |  | 11-006 | 11-026 | 12-021F | 12-054F |  |  |  |  |  |  |  |  |  |  |  |  |  |  |  |  |  |  |  |  | APP |  | 5221B |  | 09-043 |  |  | 10-001A |  |  |
| 15221210 |  | Module #2 Matrix Fabrication | 64d | 2009-08-31 | 2009-12-01 | 9-090M FS+226d | 695d | 611d |  | PROCUREMENT>$50K 69 NO ESCALATION | 12,842 | CHUDAKOV | 1 | 1 |  | D |  | EUGENE C |  |  |  | 11-006 | 11-026 | 12-021F | 12-054F |  |  |  |  |  |  |  |  |  |  |  |  |  |  |  |  |  |  |  |  | APP |  | 5221B |  | 09-043 |  |  | 10-001A |  |  |
| 15221215 |  | Module #2 Machining and Shipping | 108d | 2009-08-31 | 2010-02-10 | 9-090M FS+226d | 646d | 0d |  | PROCUREMENT>$50K 69 NO ESCALATION | 4,607 | CHUDAKOV | 1 | 1 |  | D |  | EUGENE C | 09-014 |  |  | 11-006 | 11-026 | 12-021F | 12-054F |  |  |  |  |  |  |  |  |  |  |  |  |  |  |  |  |  |  |  |  | APP |  | 5221B |  | 09-043 |  |  | 10-001A |  |  |
| 15221220 |  | Module #3 Matrix Fabrication | 85d | 2009-08-31 | 2010-01-07 | 9-090M FS+226d | 674d | 590d |  | PROCUREMENT>$50K 69 NO ESCALATION | 12,842 | CHUDAKOV | 1 | 1 |  | D |  | EUGENE C | 09-014 |  |  | 11-006 | 11-026 | 12-021F | 12-054F |  |  |  |  |  |  |  |  |  |  |  |  |  |  |  |  |  |  |  |  | APP |  | 5221B |  | 09-043 |  |  | 10-001A |  |  |
| 15221225 |  | Module #3 Machining and Shipping | 108d | 2009-08-31 | 2010-02-10 | 9-090M FS+226d | 646d | 0d |  | PROCUREMENT>$50K 69 NO ESCALATION | 4,607 | CHUDAKOV | 1 | 1 |  | D |  | EUGENE C | 09-014 |  |  | 11-006 | 11-026 | 12-021F | 12-054F |  |  |  |  |  |  |  |  |  |  |  |  |  |  |  |  |  |  |  |  | APP |  | 5221B |  | 09-043 |  |  | 10-001A |  |  |
| 15221230 |  | Module #4 Matrix Fabrication | 85d | 2009-08-31 | 2010-01-07 | 9-090M FS+226d | 674d | 590d |  | PROCUREMENT>$50K 69 NO ESCALATION | 12,842 | CHUDAKOV | 1 | 1 |  | D |  | EUGENE C | 09-014 |  |  | 11-006 | 11-026 | 12-021F | 12-054F |  |  |  | 08-016 |  |  |  |  |  |  |  |  |  |  |  |  |  |  |  |  | APP |  | 5221B |  | 09-043 |  |  | 10-001A |  |  |
| 15221235 |  | Module #4 Machining and Shipping | 108d | 2009-08-31 | 2010-02-10 | 9-090M FS+226d | 646d | 0d |  | PROCUREMENT>$50K 69 NO ESCALATION | 4,607 | CHUDAKOV | 1 | 1 |  | D |  | EUGENE C |  |  |  | 11-006 | 11-026 | 12-021F | 12-054F |  |  |  |  |  |  |  |  |  |  |  |  |  |  |  |  |  |  |  |  | APP |  | 5221B |  | 09-043 |  |  | 10-001A |  |  |
| 15221240 |  | Module #5 Matrix Fabrication | 110d | 2009-08-31 | 2010-02-12 | 9-090M FS+226d, 15221045 | 649d | 565d |  | PROCUREMENT>$50K 69 NO ESCALATION | 12,842 | CHUDAKOV | 1 | 1 |  | D |  | EUGENE C |  |  |  | 11-006 | 11-026 | 12-021F | 12-054F |  |  |  |  |  |  |  |  |  |  |  |  |  |  |  |  |  |  |  |  | APP |  | 5221B |  | 09-043 |  |  | 10-001A |  |  |
| 15221245 |  | Module #5 Machining and Shipping | 161d | 2009-08-31 | 2010-04-27 | 9-090M FS+226d | 593d | 0d |  | PROCUREMENT>$50K 69 NO ESCALATION | 4,607 | CHUDAKOV | 1 | 1 |  | D |  | EUGENE C |  |  |  | 11-006 | 11-026 | 12-021F | 12-054F |  |  |  |  |  |  |  |  |  |  |  |  |  |  |  |  |  |  |  |  | APP |  | 5221B |  | 09-043 |  |  | 10-001A |  |  |
| 15221250 |  | Module #6 Matrix Fabrication | 110d | 2009-08-31 | 2010-02-12 | 9-090M FS+226d | 649d | 565d |  | PROCUREMENT>$50K 69 NO ESCALATION | 12,842 | CHUDAKOV | 1 | 1 |  | D |  | EUGENE C | 09-014 |  |  | 11-006 | 11-026 | 12-021F | 12-054F |  |  |  |  |  |  |  |  |  |  |  |  |  |  |  |  |  |  |  |  | APP |  | 5221B |  | 09-043 |  |  | 10-001A |  |  |
| 15221255 |  | Module #6 Machining and Shipping | 161d | 2009-08-31 | 2010-04-27 | 9-090M FS+226d | 593d | 0d |  | PROCUREMENT>$50K 69 NO ESCALATION | 4,607 | CHUDAKOV | 1 | 1 |  | D |  | EUGENE C | 09-014 |  |  | 11-006 | 11-026 | 12-021F | 12-054F |  |  |  |  |  |  |  |  |  |  |  |  |  |  |  |  |  |  |  |  | APP |  | 5221B |  | 09-043 |  |  | 10-001A |  |  |
| 15221260 |  | Module #7 Matrix Fabrication | 137d | 2009-08-31 | 2010-03-24 | 9-090M FS+226d | 622d | 538d |  | PROCUREMENT>$50K 69 NO ESCALATION | 12,842 | CHUDAKOV | 1 | 1 |  | D |  | EUGENE C | 09-014 |  |  | 11-006 | 11-026 | 12-021F | 12-054F |  |  |  |  |  |  |  |  |  |  |  |  |  |  |  |  |  |  |  |  | APP |  | 5221B |  | 09-043 |  |  | 10-001A |  |  |
| 15221265 |  | Module #7 Machining and Shipping | 161d | 2009-08-31 | 2010-04-27 | 9-090M FS+226d | 593d | 0d |  | PROCUREMENT>$50K 69 NO ESCALATION | 4,607 | CHUDAKOV | 1 | 1 |  | D |  | EUGENE C |  |  |  | 11-006 | 11-026 | 12-021F | 12-054F |  |  |  |  |  |  |  |  |  |  |  |  |  |  |  |  |  |  |  |  | APP |  | 5221B |  | 09-043 |  |  | 10-001A |  |  |
| 15221270 |  | Module #8 Matrix Fabrication | 137d | 2009-08-31 | 2010-03-24 | 9-090M FS+226d | 622d | 538d |  | PROCUREMENT>$50K 69 NO ESCALATION | 12,842 | CHUDAKOV | 1 | 1 |  | D |  | EUGENE C |  |  |  | 11-006 | 11-026 | 12-021F | 12-054F |  |  |  |  |  |  |  |  |  |  |  |  |  |  |  |  |  |  |  |  | APP |  | 5221B |  | 09-043 |  |  | 10-001A |  |  |
| 15221275 |  | Module #8 Machining and Shipping | 161d | 2009-08-31 | 2010-04-27 | 9-090M FS+226d | 593d | 0d |  | PROCUREMENT>$50K 69 NO ESCALATION | 4,607 | CHUDAKOV | 1 | 1 |  | D |  | EUGENE C |  |  |  | 11-006 | 11-026 | 12-021F | 12-054F |  |  |  |  |  |  |  |  |  |  |  |  |  |  |  |  |  |  |  |  | APP |  | 5221B |  | 09-043 |  |  | 10-001A |  |  |
| 15221014 |  | Proc SciFi Mods P-2 FY10 October Delivery | 38d | 2009-09-09 | 2009-10-30 | 9-090M FS+232d, 15221012 FS-16d | 220d | 0d |  | PROCUREMENT<$50K 60 NO ESCALATION; PROCUREMENT>$50K 69 NO ESCALATION | 103,944 | CHUDAKOV | 1 | 1 |  | D | 07-024 | EUGENE C |  |  |  | 11-006 | 11-026 | 12-021F | 12-054F |  |  |  |  |  |  |  |  |  |  |  |  |  |  |  |  |  | 1 | CVL |  | APP | 09-004 | 5221A |  |  |  | 09-052 |  |  |  |
| 15221016 |  | Proc SciFi Mods P-2 FY10 November Delivery | 57d | 2009-09-09 | 2009-11-30 | 15221014 FS-38d | 220d | 0d |  | PROCUREMENT>$50K 69 NO ESCALATION | 103,944 | CHUDAKOV | 1 | 1 |  | D | 07-024 | EUGENE C |  |  |  | 11-006 | 11-026 | 12-021F | 12-054F |  |  |  |  |  |  |  |  |  |  |  |  |  |  |  |  |  | 1 | CVL |  | APP | 09-004 | 5221A |  |  |  | 09-052 |  |  |  |
| 15221018 |  | Proc SciFi Mods P-2 FY10 December Delivery | 74d | 2009-09-09 | 2009-12-30 | 15221016 FS-57d | 220d | 0d |  | PROCUREMENT>$50K 69 NO ESCALATION | 103,944 | CHUDAKOV | 1 | 1 |  | D | 07-024 | EUGENE C |  |  |  | 11-006 | 11-026 | 12-021F | 12-054F |  |  |  | 08-016 |  |  |  |  |  |  |  |  |  |  |  |  |  | 1 |  |  | APP | 09-004 | 5221A |  |  | 09-012 | 09-052 |  |  |  |
| 15221018A |  | Proc SciFi Mods P-2 FY10 January Delivery | 94d | 2009-09-09 | 2010-01-29 | 15221018 FS-74d | 220d | 0d |  | PROCUREMENT>$50K 69 NO ESCALATION | 103,944 | CHUDAKOV | 1 | 1 |  | D |  | EUGENE C |  |  |  | 11-006 | 11-026 | 12-021F | 12-054F |  |  |  |  |  |  |  |  |  |  |  |  |  |  |  |  |  | 1 |  |  | APP |  | 5221A |  |  |  | 09-052 |  |  |  |
| 15221018B |  | Proc SciFi Mods P-2 FY10 February Delivery | 113d | 2009-09-09 | 2010-02-26 | 15221018A FS-94d | 220d | 0d |  | PROCUREMENT>$50K 69 NO ESCALATION | 103,944 | CHUDAKOV | 1 | 1 |  | D |  | EUGENE C |  |  |  | 11-006 | 11-026 | 12-021F | 12-054F |  |  |  |  |  |  |  |  |  |  |  |  |  |  |  |  |  | 1 |  |  | APP |  | 5221A |  |  |  | 09-052 |  |  |  |
| 15221018C |  | Proc SciFi Mods P-2 FY10 March Delivery | 136d | 2009-09-09 | 2010-03-31 | 15221018B FS-113d | 220d | 0d |  | PROCUREMENT>$50K 69 NO ESCALATION | 103,944 | CHUDAKOV | 1 | 1 |  | D |  | EUGENE C |  |  |  | 11-006 | 11-026 | 12-021F | 12-054F |  |  |  |  |  |  |  |  |  |  |  |  |  |  |  |  |  | 1 |  |  | APP |  | 5221A |  |  |  | 09-052 |  |  |  |
| 15221018D |  | Proc SciFi Mods P-2 FY10 April Delivery | 158d | 2009-09-09 | 2010-04-30 | 15221018C FS-136d | 220d | 0d |  | PROCUREMENT>$50K 69 NO ESCALATION | 103,944 | CHUDAKOV | 1 | 1 |  | D |  | EUGENE C |  |  |  | 11-006 | 11-026 | 12-021F | 12-054F |  |  |  |  |  |  |  |  |  |  |  |  |  |  |  |  |  | 1 |  |  | APP |  | 5221A |  |  |  | 09-052 |  |  |  |
| 15221018F |  | Proc SciFi Mods P-2 FY10 May Delivery | 178d | 2009-09-09 | 2010-05-28 | 15221018D FS-158d | 220d | 0d |  | PROCUREMENT>$50K 69 NO ESCALATION | 103,944 | CHUDAKOV | 1 | 1 |  | D |  | EUGENE C |  |  |  | 11-006 | 11-026 | 12-021F | 12-054F |  |  |  |  |  |  |  |  |  |  |  |  |  |  |  |  |  | 1 |  |  | APP |  | 5221A |  |  |  | 09-052 |  |  |  |
| 15221018G |  | Proc SciFi Mods P-2 FY10 June Delivery | 200d | 2009-09-09 | 2010-06-30 | 15221018F FS-178d | 220d | 0d |  | PROCUREMENT>$50K 69 NO ESCALATION | 103,944 | CHUDAKOV | 1 | 1 |  | D |  | EUGENE C |  |  |  | 11-006 | 11-026 | 12-021F | 12-054F |  |  |  |  |  |  |  |  |  |  |  |  |  |  |  |  |  | 1 |  |  | APP |  | 5221A |  |  |  | 09-052 |  |  |  |
| 15221018H |  | Proc SciFi Mods P-2 FY10 July Delivery | 221d | 2009-09-09 | 2010-07-30 | 15221018G FS-200d | 220d | 0d |  | PROCUREMENT>$50K 69 NO ESCALATION | 103,944 | CHUDAKOV | 1 | 1 |  | D |  | EUGENE C |  |  |  | 11-006 | 11-026 | 12-021F | 12-054F |  |  |  |  |  |  |  |  |  |  |  |  |  |  |  |  |  | 1 |  |  | APP |  | 5221A |  |  |  | 09-052 |  |  |  |
| 15221018J |  | Proc SciFi Mods P-2 FY10 August Delivery | 243d | 2009-09-09 | 2010-08-31 | 15221018H FS-221d | 220d | 0d |  | PROCUREMENT>$50K 69 NO ESCALATION | 103,944 | CHUDAKOV | 1 | 1 |  | D |  | EUGENE C |  |  |  | 11-006 | 11-026 | 12-021F | 12-054F |  |  |  |  |  |  |  |  |  |  |  |  |  |  |  |  |  | 1 |  |  | APP |  | 5221A |  |  |  | 09-052 |  |  |  |
| 15221018K |  | Proc SciFi Mods P-2 FY10 September Delivery | 264d | 2009-09-09 | 2010-09-30 | 15221018J FS-243d | 220d | 0d |  | PROCUREMENT>$50K 69 NO ESCALATION | 103,944 | CHUDAKOV | 1 | 1 |  | D |  | EUGENE C |  |  |  | 11-006 | 11-026 | 12-021F | 12-054F |  |  |  |  |  |  |  |  |  |  |  |  |  |  |  |  |  | 1 |  |  | APP |  | 5221A |  |  |  | 09-052 |  |  |  |
| 15221012A |  | Proc SciFi Mods P-1 Correction to Match award per CR09-052 | 1d | 2009-09-17 | 2009-09-17 | 9-090M FS+238d | 9d |  |  | PROCUREMENT>$50K 69 | -1,448.4 | CHUDAKOV | 1 | 1 |  | D | 07-024 | EUGENE C |  |  |  |  |  |  |  |  |  |  | 08-016 |  |  |  |  |  |  |  |  |  |  |  |  |  | 1 | CVL | 5 | APP | 09-004 | 5221A |  |  | 09-012 | 09-052 |  |  |  |
| 15221090 |  | Proc Lead Sheets 31-36 (BarCal) | 60d | 2009-09-21 | 2009-12-15 | 15221080 | 424d | 0d |  | PROCUREMENT<$50K 60 NO ESCALATION FY10 | 24,490.81 | CHUDAKOV | 1 | 1 |  | D |  | EUGENE C |  |  |  | 11-006 | 11-026 | 12-021F | 12-054F |  |  |  | 08-016 |  |  |  |  |  |  |  |  |  |  |  |  |  |  |  |  |  |  |  |  |  | 09-012 |  |  |  |  |
| 15221005 |  | FY10 Engineering Support for Procurements (BarCal) | 248d | 2009-10-01 | 2010-09-30 | 9-100M | 399d | 121d |  | MECH ENG [40 h]; MECH DES [20 h] | 3,538.8 | CHUDAKOV | 1 | 1 |  | D | 07-024 | EUGENE C |  | 09-027 | 09-027 | 11-006 | 11-026 | 12-021F | 12-054F |  |  |  |  |  |  |  |  |  |  |  |  |  |  |  |  |  |  |  |  |  |  |  |  |  |  |  |  |  |  |
| 15221010E |  | FY10 Travel (BarCal) | 248d | 2009-10-01 | 2010-09-30 | 15221009E | 496d | 0d |  | TRAVEL | 7,617.88 | CHUDAKOV | 1 | 1 |  | D | 07-024 | EUGENE C |  |  |  | 11-006 | 11-026 |  |  |  |  |  |  |  |  |  |  |  |  |  |  |  |  |  |  |  |  |  |  |  |  |  |  |  |  |  |  |  |  |
| 15221100 |  | Proc Lead Sheets 13-18 (BarCal) | 60d | 2009-12-16 | 2010-03-19 | 15221090, 9-100M | 424d | 0d |  | PROCUREMENT<$50K 60 | 25,272.07 | CHUDAKOV | 1 | 1 |  | D |  | EUGENE C |  |  |  | 11-006 | 11-026 | 12-021F | 12-054F |  |  |  |  |  |  |  |  |  |  |  |  |  |  |  |  |  |  |  |  |  |  |  |  |  |  |  |  |  |  |
| 15221165 |  | Proc PMT's & Dividers (BarCal) | 120d | 2010-01-05 | 2010-06-24 | 9-100M FS+60d | 557d | 535d |  |  |  | CHUDAKOV | 1 | 1 |  | D |  | EUGENE C |  |  |  | 11-006 | 11-026 | 12-021F | 12-054F |  |  |  |  |  |  |  |  |  |  |  |  |  |  |  |  |  |  |  |  |  |  |  |  | 09-043 |  |  |  | 10-024 |  |
| 15221115 |  | Proc Lead Sheets 37-42 (BarCal) | 60d | 2010-03-22 | 2010-06-14 | 15221100 | 424d | 0d |  | PROCUREMENT<$50K 60 | 25,272.07 | CHUDAKOV | 1 | 1 |  | D |  | EUGENE C |  |  |  | 11-006 | 11-026 | 12-021F | 12-054F |  |  |  |  |  |  |  |  |  |  |  |  |  |  |  |  |  |  |  |  |  |  |  |  |  |  |  |  |  |  |
| 15221003 |  | Prep Procur Packages for Si PM's/Winston Cones 2010 (BarCal) | 60d | 2010-04-01 | 2010-06-24 | 9-100M FS+120d | 278d | 0d |  | MECH ENG [400 h]; MECH DES [560 h] | 51,674.4 | CHUDAKOV | 1 | 1 | 2 | D | 07-024 | EUGENE C | 09-014 | 09-027 | 09-027 | 11-006 | 11-026 | 12-021F | 12-054F |  |  |  |  |  |  |  |  |  |  |  |  |  |  |  |  |  |  |  |  |  |  |  |  |  |  |  |  |  | 10-002 |
| 15221130 |  | Proc Lead Sheets 19-24 (BarCal) | 60d | 2010-06-15 | 2010-09-08 | 15221115 | 424d | 0d |  | PROCUREMENT<$50K 60 | 25,272.07 | CHUDAKOV | 1 | 1 |  | D |  | EUGENE C |  |  |  | 11-006 | 11-026 | 12-021F | 12-054F |  |  |  |  |  |  |  |  |  |  |  |  |  |  |  |  |  |  |  |  |  |  |  |  |  |  |  |  |  |  |

| ID | Activity | Type | Duration | Start | Finish | Predecessors | Total float | Free float | Resources | Cost | RESP - Responsibility | STRT%COMP for CM EVM | FNSH%COMP for CM EVM | 12 GeV 2nd level Critical Path | HALL D Related Milestones | CR 07-024 | CAM RESPONSIBLE | CR 09-014 | CR 09-027 | CR 09-027 Repair | CR 10-002 | CR 11-006 | CR 11-026 | CR 12-021 | CR 12-054 | Inter Project Link (IPL) | Advance Purchase Plan > 500K | 12 GEV MAJOR PROCUREMENT CATAGORY | CR 10-024 | CR 11-001 | CR 11-054 | CR 08-016 | CR 09-012 | CR 09-043 | 12 GeV 1st level Critical Path | CIVIL CRITICAL MILESTONES | CR 11-019 | CR 12-055 | CR 10-042 | CR 11-011 | CR 11-040 | CR 11-049 | CR 12-001 | CR 11-048 | CR 12-017 | CR 09-052 | CR 12-053 | Profile change |
| --- | --- | --- | --- | --- | --- | --- | --- | --- | --- | --- | --- | --- | --- | --- | --- | --- | --- | --- | --- | --- | --- | --- | --- | --- | --- | --- | --- | --- | --- | --- | --- | --- | --- | --- | --- | --- | --- | --- | --- | --- | --- | --- | --- | --- | --- | --- | --- | --- |
| 15221004 | Prep Light Guide Procurement Package (BarCal) |  | 59d | 2010-06-25 | 2010-09-17 | 15221003 | 278d | 0d | MECH DES [160 h]; MECH ENG [80 h] | 12,506.4 | CHUDAKOV | 1 | 1 | 2 | D | 07-024 | EUGENE C | 09-014 | 09-027 | 09-027 | 10-002 | 11-006 | 11-026 | 12-021F | 12-054F |  |  |  |  |  |  |  |  |  |  |  |  |  |  |  |  |  |  |  |  |  |  |  |
| 15221160a | SiPM Elec Preamp/Sum, Temp stab, Mech cooling FY10 |  | 68d | 2010-06-25 | 2010-09-30 | 15221003 FS-120d, 9-100M FS+180d | 437d | 0d | SUPPLIES & MATERIALS; ELEC DES [1065.33 h]; ELEC ENG [1065.33 h]; ELEC TECH [1065.33 h] | 190,796.61 | CHUDAKOV | 1 | 1 |  | D |  | EUGENE C |  |  |  |  | 11-006 | 11-026 | 12-021F | 12-054F | IPL | APP | 5221C | 10-024 | 11-001 | 11-054 |  |  |  |  |  |  |  |  |  |  |  |  |  |  |  |  |  |
| 15221160b | Mechanical Drawings Including Temperature Stability (BarCal) (IPL 55221010 and 55221010c) FY10 |  | 68d | 2010-06-25 | 2010-09-30 | 9-100M FS+180d, 15221003 FS-120d | 489d | 467d | MECH ENG [294.67 h] | 19,404.02 | CHUDAKOV | 1 | 1 |  | D |  | EUGENE C |  |  |  |  | 11-006 | 11-026 | 12-021F | 12-054F | IPL | APP | 5221C | 10-024 | 11-001 |  |  |  |  |  |  |  |  |  |  |  |  |  |  |  |  |  |  |
| 15221145 | Proc Lead Sheets 43-48 (BarCal) |  | 60d | 2010-09-09 | 2010-12-03 | 15221130 | 424d | 263d | PROCUREMENT<$50K 60 NO ESCALATION FY11 | 25,272.07 | CHUDAKOV | 1 | 1 |  | D |  | EUGENE C |  |  |  |  | 11-006 | 11-026 | 12-021F | 12-054F |  |  |  |  |  |  | 08-016 | 09-012 | 09-043 |  |  |  |  |  |  |  |  |  |  |  |  |  |  |
| 15221173 | Proc Light Guides (BarCal) |  | 220d | 2010-09-20 | 2011-08-09 | 15221004, 15221005 FS-130d, 12322018M, 9-100M FS+120d | 278d | 194d |  |  | CHUDAKOV | 1 | 1 |  | D |  | EUGENE C | 09-014 |  |  | 10-002 | 11-006 | 11-026 | 12-021F | 12-054F |  |  |  | 10-024 |  |  | 08-016 |  |  |  |  |  |  |  |  |  |  |  |  |  |  |  |  |
| 15221008 | Prep Procur Packages Shipping Fixture/Support Frame 2011 (BarCal) |  | 60d | 2010-10-01 | 2011-01-04 | 9-110M | 539d | 266d | MECH DES [200 h] | 9,336 | CHUDAKOV | 1 | 1 | 2 | D | 07-024 | EUGENE C | 09-014 | 09-027 | 09-027 |  | 11-006 | 11-026 | 12-021F |  |  |  |  |  |  |  |  |  |  |  |  |  |  |  |  |  |  |  |  |  |  |  |  |
| 15221011E | FY11 Travel (BarCal) |  | 248d | 2010-10-01 | 2011-09-30 | 15221010E | 496d | 0d | TRAVEL | 7,860.89 | CHUDAKOV | 1 | 1 |  | D | 07-024 | EUGENE C |  |  |  |  | 11-006 | 11-026 |  |  |  |  |  |  |  |  |  |  |  |  |  |  |  |  |  |  |  |  |  |  |  |  |  |
| 15221018N | Proc SciFi Mods P-3 FY11 December Delivery |  | 58d | 2010-10-01 | 2010-12-30 | 195221001 FS-41d | 220d | 0d | PROCUREMENT<$50K 60 NO ESCALATION; PROCUREMENT>$50K 69 NO ESCALATION | 104,886.31 | CHUDAKOV | 1 | 1 |  | D |  | EUGENE C |  |  |  |  | 11-006 | 11-026 | 12-021F | 12-054F |  | APP | 5221A |  |  |  |  |  |  | 1 | CVL | 11-019 |  |  |  |  |  |  |  |  |  |  |  |
| 15221018P | Proc SciFi Mods P-3 FY11 January Delivery |  | 78d | 2010-10-01 | 2011-01-31 | 15221018N FS-58d | 220d | 0d | PROCUREMENT<$50K 60 NO ESCALATION; PROCUREMENT>$50K 69 NO ESCALATION | 104,886.31 | CHUDAKOV | 1 | 1 |  | D |  | EUGENE C |  |  |  |  | 11-006 | 11-026 | 12-021F | 12-054F |  | APP | 5221A |  |  |  |  |  |  | 1 | CVL | 11-019 |  |  |  |  |  |  |  |  |  |  |  |
| 15221018Q | Proc SciFi Mods P-3 FY11 February Delivery |  | 97d | 2010-10-01 | 2011-02-28 | 15221018P FS-78d | 220d | 0d | PROCUREMENT>$50K 69 NO ESCALATION; PROCUREMENT<$50K 60 NO ESCALATION | 104,886.31 | CHUDAKOV | 1 | 1 |  | D |  | EUGENE C |  |  |  |  | 11-006 | 11-026 | 12-021F | 12-054F |  | APP | 5221A |  |  |  |  |  |  | 1 |  | 11-019 |  |  |  |  |  |  |  |  |  |  |  |
| 15221018R | Proc SciFi Mods P-3 FY11 March Delivery |  | 120d | 2010-10-01 | 2011-03-31 | 15221018Q FS-97d | 220d | 0d | PROCUREMENT>$50K 69 NO ESCALATION; PROCUREMENT<$50K 60 NO ESCALATION | 104,886.31 | CHUDAKOV | 1 | 1 |  | D |  | EUGENE C |  |  |  |  | 11-006 | 11-026 | 12-021F | 12-054F |  | APP | 5221A |  |  |  |  |  |  | 1 |  | 11-019 |  |  |  |  |  |  |  |  |  |  |  |
| 15221018S | Proc SciFi Mods P-3 FY11 April Delivery |  | 141d | 2010-10-01 | 2011-04-29 | 15221018R FS-120d | 220d | 0d | PROCUREMENT<$50K 60 NO ESCALATION; PROCUREMENT>$50K 69 NO ESCALATION | 104,886.31 | CHUDAKOV | 1 | 1 |  | D |  | EUGENE C |  |  |  |  | 11-006 | 11-026 | 12-021F | 12-054F |  | APP | 5221A |  |  |  |  |  |  | 1 |  | 11-019 |  |  |  |  |  |  |  |  |  |  |  |
| 15221018T | Proc SciFi Mods P-3 FY11 May Delivery |  | 162d | 2010-10-01 | 2011-05-31 | 15221018S FS-141d | 220d | 0d | PROCUREMENT<$50K 60 NO ESCALATION; PROCUREMENT>$50K 69 NO ESCALATION | 104,886.31 | CHUDAKOV | 1 | 1 |  | D |  | EUGENE C |  |  |  |  | 11-006 | 11-026 | 12-021F | 12-054F |  | APP | 5221A |  |  |  |  |  |  | 1 |  | 11-019 |  |  |  |  |  |  |  |  |  |  |  |
| 15221018U | Proc SciFi Mods P-3 FY11 June Delivery |  | 184d | 2010-10-01 | 2011-06-30 | 15221018T FS-162d | 220d | 0d | PROCUREMENT<$50K 60 NO ESCALATION; PROCUREMENT>$50K 69 NO ESCALATION | 101,771.83 | CHUDAKOV | 1 | 1 |  | D |  | EUGENE C |  |  |  |  | 11-006 | 11-026 | 12-021F | 12-054F |  | APP | 5221A |  |  |  |  |  |  | 1 |  | 11-019 |  |  |  |  |  |  |  |  |  |  |  |
| 15221018V | Proc SciFi Mods P-3 FY11 July Delivery |  | 204d | 2010-10-01 | 2011-07-29 | 15221018U FS-184d | 220d | 0d | PROCUREMENT>$50K 69 NO ESCALATION; PROCUREMENT<$50K 60 NO ESCALATION | 101,771.83 | CHUDAKOV | 1 | 1 |  | D |  | EUGENE C |  |  |  |  | 11-006 | 11-026 | 12-021F | 12-054F |  | APP | 5221A |  |  |  |  |  |  | 1 |  | 11-019 |  |  |  |  |  |  |  |  |  |  |  |
| 15221018W | Proc SciFi Mods P-3 FY11 August Delivery |  | 227d | 2010-10-01 | 2011-08-31 | 15221018V FS-204d | 220d | 0d | PROCUREMENT>$50K 69 NO ESCALATION; PROCUREMENT<$50K 60 NO ESCALATION | 101,771.83 | CHUDAKOV | 1 | 1 |  | D |  | EUGENE C |  |  |  |  | 11-006 | 11-026 | 12-021F | 12-054F |  | APP | 5221A |  |  |  |  |  |  | 1 |  | 11-019 |  |  |  |  |  |  |  |  |  |  |  |
| 15221018X | Proc SciFi Mods P-3 FY11 September Delivery |  | 248d | 2010-10-01 | 2011-09-30 | 15221018W FS-227d | 220d | 59d | PROCUREMENT>$50K 69 NO ESCALATION; PROCUREMENT<$50K 60 NO ESCALATION | 101,771.83 | CHUDAKOV | 1 | 1 |  | D |  | EUGENE C |  |  |  |  | 11-006 | 11-026 | 12-021F | 12-054F |  | APP | 5221A |  |  |  |  |  |  | 1 |  | 11-019 |  |  |  |  |  |  |  |  |  |  |  |
| 15221160ab | SiPM Elec Preamp/Sum, Temp stab, Mech cooling FY11 Part A |  | 52d | 2010-10-01 | 2010-12-15 | 15221160a | 437d | 260d | ELEC ENG [814.67 h]; ELEC TECH [814.67 h]; MECH ENG [225.33 h]; PROCUREMENT<$50K 60; SUPPLIES & MATERIALS; ELEC DES [814.67 h] | 200,861.89 | CHUDAKOV | 1 | 1 |  | D |  | EUGENE C |  |  |  |  | 11-006 | 11-026 | 12-021F | 12-054F | IPL | APP | 5221C | 10-024 | 11-001 | 11-054 |  |  |  |  |  |  | 12-055 |  |  |  |  |  |  |  |  |  |  |
| 15221160aba | SiPM Elec Preamp/Sum, Temp stab, Mech cooling FY11 Part B |  | 52d | 2010-10-01 | 2010-12-15 | 15221160a | 437d | 260d | PROCUREMENT<$50K 60; PROCUREMENT>$50K 69 | 65,000 | CHUDAKOV | 1 | 1 |  | D |  | EUGENE C |  |  |  |  | 11-006 | 11-026 | 12-021F | 12-054F | IPL | APP | 5221C | 10-024 | 11-001 | 11-054 |  |  |  |  |  |  | 12-055 |  |  |  |  |  |  |  |  |  |  |
| 15221157M | SiPM Contract Award (APP) | milestone | 0d | 2010-11-30 | 2010-11-30 | 9-110M FS+40d | 312d | 0d |  |  | CHUDAKOV | 1 | 1 |  | D |  | EUGENE C |  |  |  | 10-002 | 11-006 | 11-026 |  |  | IPL | APP | 5221C | 10-024 |  |  |  |  | 09-043 |  |  |  |  | 10-042 | 11-011 | 11-040 | 11-049 |  |  |  |  |  |  |
| 15221158 | Vend Fab SiPMs Peg Point #1 - First Article |  | 56d | 2010-12-01 | 2011-02-28 | 9-110M FS+41d, 15221157M | 334d | 22d | PROCUREMENT<$50K 60 NO ESCALATION; PROCUREMENT>$50K 69 NO ESCALATION | 86,720 | CHUDAKOV | 1 | 1 |  | D |  | EUGENE C |  |  |  | 10-002 | 11-006 | 11-026 |  |  | IPL | APP | 5221C | 10-024 |  |  |  |  | 09-043 |  |  |  |  | 10-042 | 11-011 | 11-040 | 11-049 |  |  |  |  |  |  |
| 15221159 | Vend Fab SiPMs Peg Point #2 - Production Delivery #1 Qty 500 |  | 163d | 2010-12-01 | 2011-07-29 | 15221158M FS-101d | 312d | 0d | PROCUREMENT>$50K 69 NO ESCALATION | 262,500 | CHUDAKOV | 1 | 1 |  | D |  | EUGENE C |  |  |  |  | 11-006 | 11-026 |  |  | IPL | APP | 5221C |  |  |  |  |  |  |  |  |  |  |  | 11-011 | 11-040 | 11-049 |  |  |  |  |  |  |
| 15221159a | Vend Fab SiPMs Peg Point #3 - Production Delivery #2 Qty 500 |  | 186d | 2010-12-01 | 2011-08-31 | 15221159 FS-163d | 495d | 0d | PROCUREMENT>$50K 69 NO ESCALATION | 262,500 | CHUDAKOV | 1 | 1 |  | D |  | EUGENE C |  |  |  |  | 11-006 | 11-026 |  |  | IPL | APP | 5221C |  |  |  |  |  |  |  |  |  |  |  | 11-011 | 11-040 |  |  |  |  |  |  |  |
| 15221159b | Vend Fab SiPMs Peg Point #4 - Production Delivery #3 Qty 120 |  | 207d | 2010-12-01 | 2011-09-30 | 15221159a FS-186d | 495d |  | PROCUREMENT>$50K 69 NO ESCALATION | 63,000 | CHUDAKOV | 1 | 1 |  | D |  | EUGENE C |  |  |  |  | 11-006 | 11-026 |  |  | IPL | APP | 5221C |  |  |  |  |  |  |  |  |  |  |  | 11-011 | 11-040 |  |  |  |  |  |  |  |
| 15221158a | SiPM First Article Testing |  | 83d | 2011-01-04 | 2011-05-02 | 15221157M FS+19d | 312d | 0d | SCIENTIST [1440 h] | 98,539.2 | CHUDAKOV | 1 | 1 |  | D |  | EUGENE C |  |  |  | 10-002 | 11-006 | 11-026 |  |  | IPL | APP | 5221C | 10-024 |  |  |  |  | 09-043 |  |  |  |  | 10-042 | 11-011 | 11-040 | 11-049 |  |  |  |  |  |  |
| 15221006 | FY11 Engineering Support for fabrication (BarCal) |  | 188d | 2011-01-05 | 2011-09-30 | 9-110M FS+60d | 115d | 93d | MECH DES [120 h]; MECH ENG [120 h] | 13,755.6 | CHUDAKOV | 1 | 1 | 2 | D |  | EUGENE C |  |  |  |  | 11-006 | 11-026 | 12-021F | 12-054F |  |  |  |  |  |  |  |  |  |  |  |  |  |  |  |  |  |  |  |  |  |  |  |
| 15221147 | Drawings Winston Cones (BarCal) |  | 103d | 2011-01-05 | 2011-06-01 | 9-110M FS+60d | 20d | 0d | MECH TECH [260 h]; MECH ENG [100 h]; SCIENTIST [160 h] | 28,942 | CHUDAKOV | 1 | 1 |  | D |  | EUGENE C |  |  |  | 10-002 | 11-006 | 11-026 | 12-021F | 12-054F |  |  |  | 10-024 |  |  |  |  | 09-043 |  |  |  |  | 10-042 |  |  |  |  |  |  |  |  |  |
| 15221158b | SiPM First Article Test set up |  | 19d | 2011-02-02 | 2011-03-01 | 15221157M FS+39d | 356d | 44d | PROCUREMENT<$50K 60 NO ESCALATION | 10,000 | CHUDAKOV | 1 | 1 |  | D |  | EUGENE C |  |  |  | 10-002 | 11-006 | 11-026 |  |  | IPL | APP | 5221C | 10-024 |  |  |  |  | 09-043 |  |  |  |  | 10-042 | 11-011 | 11-040 | 11-049 |  |  |  |  |  |  |
| 15221055 | Fabricate BCAL Calibration System (BarCal) Labor FY11 |  | 107d | 2011-05-02 | 2011-09-30 | 1152055, 9-110M FS+141d | 100d | 0d | ELEC TECH [208.82 h] | 8,931.23 | CHUDAKOV | 1 | 1 |  | D |  | EUGENE C |  |  |  |  | 11-006 | 11-026 | 12-021F | 12-054F |  |  |  |  |  |  |  |  | 09-043 |  |  |  |  | 10-042 |  |  |  | 12-001 |  |  |  |  |  |
| 15221055b | Fabricate BCAL Calibration System (BarCal) Procurement |  | 248d | 2011-05-02 | 2012-04-30 | 1152055, 9-110M FS+141d | 100d | 6d | PROCUREMENT<$50K 60 NO ESCALATION FY12 | 30,957 | CHUDAKOV | 1 | 1 |  | D |  | EUGENE C |  |  |  |  | 11-006 | 11-026 | 12-021F | 12-054F |  |  |  |  |  |  |  |  | 09-043 |  |  |  |  | 10-042 |  |  |  | 12-001 |  |  |  |  |  |
| 15221158M | SiPM Notice To Begin Production | milestone | 0d | 2011-05-03 | 2011-05-03 | 15221158b, 15221158 FS+23d, 15221158a | 312d | 0d |  |  | CHUDAKOV | 1 | 1 |  | D |  | EUGENE C |  |  |  | 10-002 | 11-006 | 11-026 |  |  | IPL | APP | 5221C | 10-024 |  |  |  |  | 09-043 |  |  |  |  | 10-042 | 11-011 | 11-040 | 11-049 |  |  |  |  |  |  |
| 15221020 | Completion of BCAL assembly work in factory, exchange rate coverage |  | 207d | 2011-08-01 | 2012-05-31 | 9-110M FS+204d | 78d | 56d | PROCUREMENT>$50K 69 NO ESCALATION; PROCUREMENT<$50K 60 NO ESCALATION | 311,000 | CHUDAKOV | 1 | 1 |  | D |  | EUGENE C |  |  |  |  |  |  | 12-021F | 12-054F |  | APP | 5221A |  |  |  |  |  |  | 1 |  |  |  |  |  |  |  |  | 11-048 |  |  |  |  |
| 15221025 | Fabrication of matrix #49 |  | 207d | 2011-08-01 | 2012-05-31 | 9-110M FS+204d | 58d | 0d | PROCUREMENT>$50K 69 NO ESCALATION | 22,400 | CHUDAKOV | 1 | 1 |  | D |  | EUGENE C |  |  |  |  |  |  | 12-021F | 12-054F |  | APP | 5221A |  |  |  |  |  |  | 1 |  |  |  |  |  |  |  |  | 11-048 |  |  |  |  |
| 15221030 | Machining and shipping of matrix #49 |  | 227d | 2011-08-01 | 2012-06-29 | 15221025 FS-207d | 58d | 36d | PROCUREMENT>$50K 69 NO ESCALATION | 4,600 | CHUDAKOV | 1 | 1 |  | D |  | EUGENE C |  |  |  |  |  |  | 12-021F | 12-054F |  | APP | 5221A |  |  |  |  |  |  | 1 |  |  |  |  |  |  |  |  | 11-048 |  |  |  |  |
| 15221150 | Proc Winston Cones First Article (Per CR12-017 This is Part of Peg Point #1) |  | 44d | 2011-08-01 | 2011-09-30 | 15221003, 15221147 FS+41d | 20d | 0d | PROCUREMENT>$50K 69 | 10,000 | CHUDAKOV | 1 | 1 |  | D |  | EUGENE C |  |  |  | 10-002 | 11-006 | 11-026 | 12-021F | 12-054F |  |  |  | 10-024 |  |  |  |  | 09-043 |  |  |  |  | 10-042 |  |  |  |  |  | 12-017 |  |  |  |
| 15221160ba | SiPM production testing FY11 |  | 44d | 2011-08-01 | 2011-09-30 | 15221159 | 312d | 0d | ELEC TECH [159.17 h]; MECH TECH [159.17 h] | 13,663.15 | CHUDAKOV | 1 | 1 |  | D |  | EUGENE C |  |  |  |  | 11-006 | 11-026 |  |  | IPL | APP | 5221C | 10-024 | 11-001 |  |  |  |  |  |  |  |  |  |  | 11-040 | 11-049 | 12-001 |  |  |  |  |  |
| 15221160bb | SiPM production testing set up (materials) |  | 227d | 2011-08-01 | 2012-06-29 | 15221159 | 312d |  | PROCUREMENT<$50K 60 NO ESCALATION FY12 | 53,999.37 | CHUDAKOV | 1 | 1 |  | D |  | EUGENE C |  |  |  |  | 11-006 | 11-026 |  |  | IPL | APP | 5221C | 10-024 | 11-001 |  |  |  |  |  |  |  |  |  |  | 11-040 | 11-049 |  |  |  |  |  |  |
| 15221007 | Prepare procurement packages for assembly tooling |  | 78d | 2011-10-03 | 2012-01-31 | 9-120M | 273d | 0d | MECH ENG [280 h]; MECH TECH [200 h]; MECH DES [400 h] | 47,789.6 | CHUDAKOV | 1 | 1 | 2 | D |  | EUGENE C |  |  |  |  | 11-006 | 11-026 | 12-021F |  |  |  |  |  |  |  |  |  |  |  |  |  |  |  |  |  |  |  |  |  |  |  |  |
| 15221012E | FY12 Travel (BarCal) |  | 247d | 2011-10-03 | 2012-09-28 | 15221011E | 496d |  | TRAVEL | 6,590.64 | CHUDAKOV | 1 | 1 |  | D | 07-024 | EUGENE C |  |  |  |  | 11-006 | 11-026 |  |  |  |  |  |  |  |  |  |  | 09-043 |  |  |  |  |  |  |  |  |  |  |  | 09-052 |  |  |
| 15221055a | Fabricate BCAL Calibration System (BarCal) Labor FY12 |  | 141d | 2011-10-03 | 2012-04-30 | 15221055 | 100d | 6d | ELEC TECH [275.18 h] | 12,143.69 | CHUDAKOV | 1 | 1 |  | D |  | EUGENE C |  |  |  |  | 11-006 | 11-026 | 12-021F | 12-054F |  |  |  |  |  |  |  |  | 09-043 |  |  |  |  | 10-042 |  |  |  | 12-001 |  |  |  |  |  |
| 15221160baa | SiPM production testing FY12 |  | 183d | 2011-10-03 | 2012-06-29 | 15221160ba | 312d |  | MECH TECH [662.01 h]; ELEC TECH [662.01 h] | 58,634.22 | CHUDAKOV | 1 | 1 |  | D |  | EUGENE C |  |  |  |  | 11-006 | 11-026 |  |  | IPL | APP | 5221C | 10-024 | 11-001 |  |  |  |  |  |  |  |  |  |  | 11-040 | 11-049 | 12-001 |  |  |  |  |  |
| 15221155 | Vend Fab Light Guides (WC) Peg Point # 1 - Materials |  | 58d | 2011-10-31 | 2012-01-31 | 9-110M FS+60d, 15221003, 15221150 FS+20d | 20d | 0d | PROCUREMENT<$50K 60 NO ESCALATION | 50,000 | CHUDAKOV | 1 | 1 |  | D |  | EUGENE C |  |  |  | 10-002 | 11-006 | 11-026 | 12-021F | 12-054F |  |  |  | 10-024 |  |  |  |  | 09-043 |  |  |  |  | 10-042 |  |  |  |  |  | 12-017 |  |  |  |
| 15221156 | Vend Fab Light Guides (WC) Peg Point # 2 - First Article Delivery |  | 58d | 2011-10-31 | 2012-01-31 | 15221155 FS-58d | 20d | 0d | PROCUREMENT>$50K 69 NO ESCALATION | 6,800 | CHUDAKOV | 1 | 1 |  | D |  | EUGENE C |  |  |  |  |  |  | 12-021F | 12-054F |  |  |  |  |  |  |  |  |  |  |  |  |  |  |  |  |  |  |  | 12-017 |  |  |  |
| 15221156a | Vend Fab Light Guides (WC) Peg Point # 3 - 1st Production Delivery |  | 100d | 2011-10-31 | 2012-03-30 | 15221156 FS-58d | 20d | 0d | PROCUREMENT>$50K 69 NO ESCALATION | 33,320 | CHUDAKOV | 1 | 1 |  | D |  | EUGENE C |  |  |  |  |  |  | 12-021F | 12-054F |  |  |  |  |  |  |  |  |  |  |  |  |  |  |  |  |  |  |  | 12-017 |  |  |  |
| 15221156b | Vend Fab Light Guides (WC) Peg Point # 4 -2nd Production Delivery |  | 121d | 2011-10-31 | 2012-04-30 | 15221156a FS-100d | 20d | 0d | PROCUREMENT>$50K 69 NO ESCALATION | 33,320 | CHUDAKOV | 1 | 1 |  | D |  | EUGENE C |  |  |  |  |  |  | 12-021F | 12-054F |  |  |  |  |  |  |  |  |  |  |  |  |  |  |  |  |  |  |  | 12-017 |  |  |  |
| 15221156c | Vend Fab Light Guides (WC) Peg Point # 5 - 3rd Production Delivery |  | 143d | 2011-10-31 | 2012-05-31 | 15221156b FS-121d | 20d | 0d | PROCUREMENT>$50K 69 NO ESCALATION | 33,320 | CHUDAKOV | 1 | 1 |  | D |  | EUGENE C |  |  |  |  |  |  | 12-021F | 12-054F |  |  |  |  |  |  |  |  |  |  |  |  |  |  |  |  |  |  |  | 12-017 |  |  |  |
| 15221156d | Vend Fab Light Guides (WC) Peg Point # 6 - 4th Production Delivery |  | 163d | 2011-10-31 | 2012-06-29 | 15221156c FS-143d | 20d | 0d | PROCUREMENT>$50K 69 NO ESCALATION | 33,320 | CHUDAKOV | 1 | 1 |  | D |  | EUGENE C |  |  |  |  |  |  | 12-021F | 12-054F |  |  |  |  |  |  |  |  |  |  |  |  |  |  |  |  |  |  |  | 12-017 |  |  |  |
| 15221156f | Vend Fab Light Guides (WC) Peg Point # 7 - 5th Production Delivery |  | 163d | 2011-10-31 | 2012-06-29 | 15221156d FS-163d | 20d | 0d | PROCUREMENT>$50K 69 NO ESCALATION | 33,320 | CHUDAKOV | 1 | 1 |  | D |  | EUGENE C |  |  |  |  |  |  | 12-021F | 12-054F |  |  |  |  |  |  |  |  |  |  |  |  |  |  |  |  |  |  |  | 12-017 |  |  |  |
| 15221156g | Vend Fab Light Guides (WC) Peg Point # 8 - 6th Production Delivery |  | 185d | 2011-10-31 | 2012-07-31 | 15221156f FS-163d | 20d | 0d | PROCUREMENT>$50K 69 NO ESCALATION | 33,320 | CHUDAKOV | 1 | 1 |  | D |  | EUGENE C |  |  |  |  |  |  | 12-021F | 12-054F |  |  |  |  |  |  |  |  |  |  |  |  |  |  |  |  |  |  |  | 12-017 |  |  |  |
| 15221156h | Vend Fab Light Guides (WC) Peg Point # 9 - 7th Production Delivery |  | 185d | 2011-10-31 | 2012-07-31 | 15221156g FS-185d | 20d | 0d | PROCUREMENT>$50K 69 NO ESCALATION | 33,320 | CHUDAKOV | 1 | 1 |  | D |  | EUGENE C |  |  |  |  |  |  | 12-021F | 12-054F |  |  |  |  |  |  |  |  |  |  |  |  |  |  |  |  |  |  |  | 12-017 |  |  |  |
| 15221156j | Vend Fab Light Guides (WC) Peg Point # 10 - 8th Production Delivery |  | 208d | 2011-10-31 | 2012-08-31 | 15221156h FS-185d | 20d | 0d | PROCUREMENT>$50K 69 NO ESCALATION | 33,320 | CHUDAKOV | 1 | 1 |  | D |  | EUGENE C |  |  |  |  |  |  | 12-021F | 12-054F |  |  |  |  |  |  |  |  |  |  |  |  |  |  |  |  |  |  |  | 12-017 |  |  |  |
| 15221156k | Vend Fab Light Guides (WC) Peg Point # 11 - 9th Production Delivery |  | 208d | 2011-10-31 | 2012-08-31 | 15221156j FS-208d | 20d | 0d | PROCUREMENT>$50K 69 NO ESCALATION | 33,320 | CHUDAKOV | 1 | 1 |  | D |  | EUGENE C |  |  |  |  |  |  | 12-021F | 12-054F |  |  |  |  |  |  |  |  |  |  |  |  |  |  |  |  |  |  |  | 12-017 |  |  |  |
| 15221156n | Vend Fab Light Guides (WC) Peg Point # 12 - 10th Production Delivery |  | 227d | 2011-10-31 | 2012-09-28 | 15221156k FS-208d | 20d | 0d | PROCUREMENT>$50K 69 NO ESCALATION | 33,320 | CHUDAKOV | 1 | 1 |  | D |  | EUGENE C |  |  |  |  |  |  | 12-021F | 12-054F |  |  |  |  |  |  |  |  |  |  |  |  |  |  |  |  |  |  |  | 12-017 |  |  |  |
| 15221161 | SiPM cool Procurement labor FY12 (FY13 @ 15221161s) |  | 183d | 2012-01-11 | 2012-09-28 | 15221160aba, 15221160ab, 9-120M FS+64d | 548d | 0d | MECH TECH [92.39 h]; ELEC TECH [369.55 h] | 20,414.05 | CHUDAKOV | 1 | 1 |  | D |  | EUGENE C |  |  |  |  | 11-006 | 11-026 | 12-021F | 12-054F | IPL | APP | 5221C | 10-024 | 11-001 | 11-054 |  |  |  |  |  |  |  |  |  |  |  |  |  |  |  | 12-053 |  |
| 15221155a | Mechanical Support (BarCal) |  | 84d | 2012-02-01 | 2012-05-30 | 15221003, 9-120M FS+78d | 294d | 274d | SUPPLIES & MATERIALS | 10,648.18 | CHUDAKOV | 1 | 1 |  | D |  | EUGENE C |  |  |  |  | 11-006 | 11-026 | 12-021F |  |  |  |  | 10-024 |  |  |  |  |  |  |  |  |  | 10-042 |  |  |  |  |  |  |  |  |  |
| 15221155b | Light Tight Boxes (BarCal) |  | 84d | 2012-02-01 | 2012-05-30 | 9-120M FS+78d, 15221003 | 294d | 274d | SUPPLIES & MATERIALS | 21,296.35 | CHUDAKOV | 1 | 1 |  | D |  | EUGENE C |  |  |  |  | 11-006 | 11-026 | 12-021F |  |  |  |  | 10-024 |  |  |  |  |  |  |  |  |  | 10-042 |  |  |  |  |  |  |  |  |  |
| 15221180 | Proc Supprt Struct and assy tooling (BarCal) Part A |  | 105d | 2012-02-01 | 2012-06-29 | 15221008, 15221007, 9-120M | 273d | 253d | PROCUREMENT>$50K 69; PROCUREMENT<$50K 60 | 92,190 | CHUDAKOV | 1 | 1 |  | D |  | EUGENE C |  |  |  |  | 11-006 | 11-026 | 12-021F |  |  |  |  |  |  |  |  |  | 09-043 |  |  |  | 12-055 | 10-042 |  |  |  |  |  |  |  |  | C |
| 15221180a | Proc Supprt Struct and assy tooling (BarCal) Part B |  | 105d | 2012-02-01 | 2012-06-29 | 9-120M, 15221007, 15221008 | 273d | 253d | PROCUREMENT>$50K 69 | 11,000 | CHUDAKOV | 1 | 1 |  | D |  | EUGENE C |  |  |  |  | 11-006 | 11-026 | 12-021F |  |  |  |  |  |  |  |  |  | 09-043 |  |  |  | 12-055 | 10-042 |  |  |  |  |  |  |  |  | C |
| 15221009 | FY12 Engineering Support for Fabrication (BarCal) |  | 126d | 2012-02-23 | 2012-08-20 | 9-120M FS+93d, 15221006 | 22d | 0d | MECH ENG [120 h]; MECH DES [80 h] | 12,268 | CHUDAKOV | 1 | 1 |  | D | 07-024 | EUGENE C |  | 09-027 | 09-027 |  | 11-006 | 11-026 | 12-021F | 12-054F |  |  |  |  |  |  |  |  | 09-043 |  |  |  |  |  |  |  |  |  |  |  |  |  |  |
| 15221057 | Installation BCAL Calibration System (BarCal) FY12 |  | 40d | 2012-08-03 | 2012-09-28 | 9-120M FS+207d, 15221055b FS+60d, 15221055a FS+60d | 203d | 0d | MECH TECH [79.62 h] | 3,538.31 | CHUDAKOV | 1 | 1 |  | D |  | EUGENE C |  |  |  |  | 11-006 | 11-026 | 12-021 |  |  |  |  |  |  |  |  |  |  |  |  |  |  | 10-042 |  |  |  |  |  |  |  | 12-053 |  |
| 15221057b | Installation BCAL Calibration System (BarCal) Procurements |  | 85d | 2012-08-03 | 2012-12-04 | 15221055b FS+60d, 9-120M FS+207d, 15221055a FS+60d | 203d |  | PROCUREMENT<$50K 60 NO ESCALATION FY13 | 21,189.87 | CHUDAKOV | 1 | 1 |  | D |  | EUGENE C |  |  |  |  | 11-006 | 11-026 | 12-021 |  |  |  |  |  |  |  |  |  |  |  |  |  |  | 10-042 |  |  |  |  |  |  |  | 12-053 |  |
| 15221057a | Installation BCAL Calibration System (BarCal) FY13 |  | 45d | 2012-10-01 | 2012-12-04 | 15221057 | 203d |  | MECH TECH [89.58 h] | 4,108.14 | CHUDAKOV | 1 | 1 |  | D |  | EUGENE C |  |  |  |  | 11-006 | 11-026 | 12-021 |  |  |  |  |  |  |  |  |  |  |  |  |  |  | 10-042 |  |  |  |  |  |  |  | 12-053 |  |
| 15221161a | SiPM cool light guide grating |  | 165d | 2012-10-01 | 2013-06-03 | 9-130M, 15221160aba, 15221160ab | 213d | 0d | PROCUREMENT<$50K 60 | 10,319 | CHUDAKOV | 1 | 1 |  | D |  | EUGENE C |  |  |  |  | 11-006 | 11-026 | 12-021 | 12-054 | IPL | APP | 5221C | 10-024 | 11-001 | 11-054 |  |  |  |  |  |  |  |  |  |  |  |  |  |  |  |  |  |
| 15221161b | SiPM cool SiPM mount |  | 165d | 2012-10-01 | 2013-06-03 | 9-130M, 15221160aba, 15221160ab | 406d | 193d | PROCUREMENT<$50K 60 | 10,319 | CHUDAKOV | 1 | 1 |  | D |  | EUGENE C |  |  |  |  | 11-006 | 11-026 | 12-021 | 12-054 | IPL | APP | 5221C | 10-024 | 11-001 | 11-054 |  |  |  |  |  |  |  |  |  |  |  |  |  |  |  |  |  |
| 15221161c | SiPM cool Cooling plate |  | 165d | 2012-10-01 | 2013-06-03 | 15221160aba, 9-130M, 15221160ab | 406d | 193d | PROCUREMENT>$50K 69; PROCUREMENT<$50K 60 | 51,595 | CHUDAKOV | 1 | 1 |  | D |  | EUGENE C |  |  |  |  | 11-006 | 11-026 | 12-021 | 12-054 | IPL | APP | 5221C | 10-024 | 11-001 | 11-054 |  |  |  |  |  |  |  |  |  |  |  |  |  |  |  |  |  |
| 15221161f | SiPM cool Electronic heat removal |  | 162d | 2012-10-01 | 2013-05-29 | 9-130M, 15221160aba, 15221160ab | 409d | 196d | PROCUREMENT<$50K 60 | 10,319 | CHUDAKOV | 1 | 1 |  | D |  | EUGENE C |  |  |  |  | 11-006 | 11-026 | 12-021 | 12-054 | IPL | APP | 5221C | 10-024 | 11-001 | 11-054 |  |  |  |  |  |  |  |  |  |  |  |  |  |  |  |  |  |
| 15221161h | SiPM cool light covers |  | 165d | 2012-10-01 | 2013-06-03 | 15221160aba, 15221160ab, 9-130M | 406d | 193d | PROCUREMENT<$50K 60 | 10,319 | CHUDAKOV | 1 | 1 |  | D |  | EUGENE C |  |  |  |  | 11-006 | 11-026 | 12-021 | 12-054 | IPL | APP | 5221C | 10-024 | 11-001 | 11-054 |  |  |  |  |  |  |  |  |  |  |  |  |  |  |  |  |  |
| 15221161j | SiPM cool cable supports/layout |  | 165d | 2012-10-01 | 2013-06-03 | 15221160aba, 9-130M, 15221160ab | 406d | 193d | PROCUREMENT<$50K 60 | 9,390.29 | CHUDAKOV | 1 | 1 |  | D |  | EUGENE C |  |  |  |  | 11-006 | 11-026 | 12-021 | 12-054 | IPL | APP | 5221C | 10-024 | 11-001 | 11-054 |  |  |  |  |  |  |  |  |  |  |  |  |  |  |  |  |  |
| 15221161k | SiPM cool cooling tubes support/layout |  | 165d | 2012-10-01 | 2013-06-03 | 15221160ab, 15221160aba, 9-130M | 406d | 193d | PROCUREMENT<$50K 60 | 10,319 | CHUDAKOV | 1 | 1 |  | D |  | EUGENE C |  |  |  |  | 11-006 | 11-026 | 12-021 | 12-054 | IPL | APP | 5221C | 10-024 | 11-001 | 11-054 |  |  |  |  |  |  |  |  |  |  |  |  |  |  |  |  |  |
| 15221161n | SiPM cool mechanical support |  | 165d | 2012-10-01 | 2013-06-03 | 9-130M, 15221160ab, 15221160aba | 406d | 193d | PROCUREMENT<$50K 60 | 12,382.8 | CHUDAKOV | 1 | 1 |  | D |  | EUGENE C |  |  |  |  | 11-006 | 11-026 | 12-021 | 12-054 | IPL | APP | 5221C | 10-024 | 11-001 | 11-054 |  |  |  |  |  |  |  |  |  |  |  |  |  |  |  |  |  |

Notes:
- 15221160a: Explanation: IPL from 6 GeV 55221010 and 55221010c
- 15221160b: Explanation: IPL from 6 GeV 55221010 and 55221010c
- 15221018N: Corrective Actions: Deleted FY12 funding predecessor since it is applied to this activities / successor.
- 15221018P: Corrective Actions: Deleted FY12 funding predecessor since it is applied to this activities / successor.
- 15221160ab: Explanation: IPL from 6 GeV 55221010 and 55221010c
- 15221160aba: Explanation: IPL from 6 GeV 55221010 and 55221010c
- 15221157M: Explanation: IPL from 6 GeV 55221010 and 55221010c
- 15221158: Explanation: IPL from 6 GeV 55221010 and 55221010c
- 15221159: Explanation: IPL from 6 GeV 55221010 and 55221010c
- 15221159a: Explanation: IPL from 6 GeV 55221010 and 55221010c
- 15221159b: Explanation: IPL from 6 GeV 55221010 and 55221010c
- 15221158a: Explanation: IPL from 6 GeV 55221010 and 55221010c
- 15221158b: Explanation: IPL from 6 GeV 55221010 and 55221010c
- 15221158M: Explanation: IPL from 6 GeV 55221010 and 55221010c
- 15221160ba: Explanation: IPL from 6 GeV 55221010 and 55221010c
- 15221160bb: Explanation: IPL from 6 GeV 55221010 and 55221010c
- 15221160baa: Explanation: IPL from 6 GeV 55221010 and 55221010c
- 15221161: Explanation: IPL from 6 GeV 55221010 and 55221010c
- 15221161a: Explanation: IPL from 6 GeV 55221010 and 55221010c
- 15221161b: Explanation: IPL from 6 GeV 55221010 and 55221010c
- 15221161c: Explanation: IPL from 6 GeV 55221010 and 55221010c
- 15221161f: Explanation: IPL from 6 GeV 55221010 and 55221010c
- 15221161h: Explanation: IPL from 6 GeV 55221010 and 55221010c
- 15221161j: Explanation: IPL from 6 GeV 55221010 and 55221010c
- 15221161k: Explanation: IPL from 6 GeV 55221010 and 55221010c
- 15221161n: Explanation: IPL from 6 GeV 55221010 and 55221010c

| ID | WBS | Activity | Duration | Start | Finish | Predecessors | Total float | Free float | Calendar | Resources | Cost | RESP - Responsibility | STRT%COMP for CM EVM | FNSH%COMP for CM EVM | Inter Project Link (IPL) | HALL D Related Milestones | Advance Purchase Plan > 500K | CAM RESPONSIBLE | 12 GEV MAJOR PROCUREMENT CATAGORY | CR 10-024 | CR 11-001 | CR 11-006 | CR 11-026 | CR 11-054 | CR 12-021 | CR 12-053 | CR 12-054 | Profile change | CR 13-014 | ReBaseline Actuals Adjustment | Original Activity ID Rebaseline | Over Under Fixed | EVMS Reporting Codes | CR 09-014 | CR 09-043 | CR 13-007 | BOE Procurement | CR 13-015 | Post Rebaseline | Obligated Prior to Rebaseline | CR 10-042 | BOE Labor | BOE Expenses | CR 14-001 | CR 07-024 | CR 08-058 | 12 GeV 2nd level Critical Path | CR 09-027 | CR 09-027 Repair | CR 08-060 | CR 09-012 | CR 10-007 | CR 08-016 | CR 10-002 | CR 10-009 |
| --- | --- | --- | --- | --- | --- | --- | --- | --- | --- | --- | --- | --- | --- | --- | --- | --- | --- | --- | --- | --- | --- | --- | --- | --- | --- | --- | --- | --- | --- | --- | --- | --- | --- | --- | --- | --- | --- | --- | --- | --- | --- | --- | --- | --- | --- | --- | --- | --- | --- | --- | --- | --- | --- | --- | --- |
| 15221161s |  | SiPM cool Procurement labor FY13 (FY12 @ 15221161) | 23d | 2012-10-01 | 2012-10-31 | 15221161 | 548d | 335d |  | MECH TECH [11.61 h]; ELEC TECH [46.45 h] | 2,647.76 | CHUDAKOV | 1 | 1 | IPL | D | APP | EUGENE C | 5221C | 10-024 | 11-001 | 11-006 | 11-026 | 11-054 | 12-021F | 12-053 | 12-054F |  |  |  |  |  |  |  |  |  |  |  |  |  |  |  |  |  |  |  |  |  |  |  |  |  |  |  |  |
| 15221182 |  | Procure BCAL SiPm chillers | 80d | 2013-01-03 | 2013-04-26 | 9-130M FS+60d | 108d |  |  | PROCUREMENT<$50K 60 | 24,765.6 | CHUDAKOV | 1 | 1 |  | D |  | EUGENE C |  |  |  |  |  |  | 12-021 |  | 12-054 | C |  |  |  |  |  |  |  |  |  |  |  |  |  |  |  |  |  |  |  |  |  |  |  |  |  |  |  |
| 15221315 |  | Re-Baseline Actuals Adjustment | 1d | 2013-08-30 | 2013-08-30 | 9-130M FS+227d | 20d |  |  | PROCUREMENT>$50K 69 NO ESCALATION | 660,502.86 | CHUDAKOV | 1 | 1 |  |  |  | EUGENE C |  |  |  |  |  |  |  |  |  |  | 13-014 | ADJ |  |  |  |  |  |  |  |  |  |  |  |  |  |  |  |  |  |  |  |  |  |  |  |  |  |
| 25221000 |  | Regina contract Decommissioning | 43d | 2013-09-03 | 2013-10-31 | 9-130M FS+228d | 224d |  | 8/5 M-F w/JLAB Holidays ReBaseline | PROCUREMENT>$50K 69 NO ESCALATION | 8,478 | CHUDAKOV | 1 | 1 |  | D |  | EUGENE C |  |  |  |  |  |  |  |  |  |  |  |  | 25221320 | y | D | 09-014 | 09-043 | 13-007 | EJ | 13-015 | PR | OB |  |  |  |  |  |  |  |  |  |  |  |  |  |  |  |
| 25221005 |  | Procured Labor (Designer) | 20d | 2013-09-03 | 2013-09-30 | 9-130M FS+228d | 247d |  | 8/5 M-F w/JLAB Holidays ReBaseline | PROCUREMENT<$50K 60 | 1,142.1 | CHUDAKOV | 1 | 1 |  | D |  | EUGENE C |  |  |  |  |  |  |  |  |  |  |  |  | 25221320 | y | D | 09-014 | 09-043 | 13-007 | EJ | 13-015 | PR | OB |  |  |  |  |  |  |  |  |  |  |  |  |  |  |  |
| 25221010 |  | Athens contract Completion | 43d | 2013-09-03 | 2013-10-31 | 9-130M FS+228d | 224d |  | 8/5 M-F w/JLAB Holidays ReBaseline | PROCUREMENT>$50K 69 NO ESCALATION | 5,125 | CHUDAKOV | 1 | 1 |  | D |  | EUGENE C |  |  |  |  |  |  |  |  |  |  |  |  | 25221320 | y | D | 09-014 | 09-043 | 13-007 | EJ | 13-015 | PR | OB |  |  |  |  |  |  |  |  |  |  |  |  |  |  |  |
| 25221010LOE |  | Forklift Rental (ESB) | 43d | 2013-09-03 | 2013-10-31 | 9-130M FS+228d | 224d |  | 8/5 M-F w/JLAB Holidays ReBaseline | PROCUREMENT<$50K 60 NO ESCALATION FY14 | 816.67 | CHUDAKOV | 1 | 1 |  | D |  | EUGENE C |  |  |  |  |  |  |  |  |  |  |  |  | 25221320 | y | D | 09-014 | 09-043 | 13-007 | EJ | 13-015 | PR | OB |  |  |  |  |  |  |  |  |  |  |  |  |  |  |  |
| 25221057b |  | Construction BCAL Pulsing System (BarCal) Labor FY13 | 20d | 2013-09-03 | 2013-09-30 | 9-130M FS+228d | 194d | 0d | 8/5 M-F w/JLAB Holidays ReBaseline | ELEC ENG [23.23 h]; MECH TECH [11.61 h]; SCIENTIST [46.45 h] | 5,608.08 | CHUDAKOV | 1 | 1 |  | D |  | EUGENE C |  |  |  | 11-006 | 11-026 |  | 12-021 | 12-053 |  |  |  |  | 25221057b |  | S |  |  | 13-007F |  | 13-015 | PR |  | 10-042 | PE |  |  |  |  |  |  |  |  |  |  |  |  |  |
| 25221057c |  | Construction BCAL Pulsing System (BarCal) Expenses FY13 | 20d | 2013-09-03 | 2013-09-30 | 9-130M FS+228d | 194d | 0d | 8/5 M-F w/JLAB Holidays ReBaseline | SUPPLIES & MATERIALS | 532.26 | CHUDAKOV | 1 | 1 |  | D |  | EUGENE C |  |  |  | 11-006 | 11-026 |  | 12-021 | 12-053 |  |  |  |  | 25221057c |  | S |  |  | 13-007F |  | 13-015 | PR |  | 10-042 |  | EJ |  |  |  |  |  |  |  |  |  |  |  |  |
| 25221060 |  | Setup and Testing of BCAL Pulsing System FY13 | 20d | 2013-09-03 | 2013-09-30 | 9-130M FS+228d | 54d | 0d | 8/5 M-F w/JLAB Holidays ReBaseline | ELEC TECH [51.61 h]; ELEC ENG [51.61 h]; SCIENTIST [51.61 h] | 9,868.99 | CHUDAKOV | 1 | 1 |  | D |  | EUGENE C |  |  |  | 11-006 | 11-026 |  | 12-021 | 12-053 |  |  |  |  | 25221060 |  | S |  |  | 13-007F |  | 13-015 | PR |  | 10-042 | PE |  |  |  |  |  |  |  |  |  |  |  |  |  |
| 25221320 |  | Procure BCAL cooling manifold | 23d | 2013-09-03 | 2013-10-03 | 9-130M FS+228d | 29d | 0d | 8/5 M-F w/JLAB Holidays ReBaseline | PROCUREMENT<$50K 60 NO ESCALATION FY14 | 9,419.84 | CHUDAKOV | 1 | 1 |  | D |  | EUGENE C |  |  |  |  |  |  |  |  |  |  |  |  | 25221320 | y | D | 09-014 | 09-043 | 13-007 | EJ | 13-015 | PR | OB |  |  |  |  |  |  |  |  |  |  |  |  |  |  |  |
| 25221057ba |  | Construction BCAL Pulsing System (BarCal) Labor FY14 | 42d | 2013-10-01 | 2013-11-27 | 9-130M FS+228d, 25221057b | 194d | 34d | 8/5 M-F w/JLAB Holidays ReBaseline | ELEC ENG [48.77 h]; MECH TECH [24.39 h]; SCIENTIST [97.55 h] | 12,152.11 | CHUDAKOV | 1 | 1 |  | D |  | EUGENE C |  |  |  | 11-006 | 11-026 |  | 12-021 | 12-053 |  |  |  |  | 25221057b |  | S |  |  | 13-007F |  | 13-015 | PR |  | 10-042 | PE |  | 14-001 |  |  |  |  |  |  |  |  |  |  |  |
| 25221057ca |  | Construction BCAL Pulsing System (BarCal) Expenses FY14 | 42d | 2013-10-01 | 2013-11-27 | 9-130M FS+228d, 25221057c | 194d | 34d | 8/5 M-F w/JLAB Holidays ReBaseline | SUPPLIES & MATERIALS | 1,153.4 | CHUDAKOV | 1 | 1 |  | D |  | EUGENE C |  |  |  | 11-006 | 11-026 |  | 12-021 | 12-053 |  |  |  |  | 25221057c |  | S |  |  | 13-007F |  | 13-015 | PR |  | 10-042 |  | EJ | 14-001 |  |  |  |  |  |  |  |  |  |  |  |
| 25221060a |  | Setup and Testing of BCAL Pulsing System FY14 | 42d | 2013-10-01 | 2013-11-27 | 25221060, 9-130M FS+228d | 54d | 37d | 8/5 M-F w/JLAB Holidays ReBaseline | ELEC TECH [108.39 h]; ELEC ENG [108.39 h]; SCIENTIST [108.39 h] | 21,384.69 | CHUDAKOV | 1 | 1 |  | D |  | EUGENE C |  |  |  | 11-006 | 11-026 |  | 12-021 | 12-053 |  |  |  |  | 25221060 |  | S |  |  | 13-007F |  | 13-015 | PR |  | 10-042 | PE |  | 14-001 |  |  |  |  |  |  |  |  |  |  |  |
|  | 2 | **1.5.2.2.2 FORWARD CALORIMETER** |  | 2009-01-02 | 2014-01-16 |  |  |  |  |  |  |  |  |  |  |  |  |  |  |  |  |  |  |  |  |  |  |  |  |  |  |  |  |  |  |  |  |  |  |  |  |  |  |  |  |  |  |  |  |  |  |  |  |  |  |
| 15222009E |  | FY09 Travel (FWD CAL) | 189d | 2009-01-02 | 2009-09-30 | 15222009EX | 317d | 0d |  | TRAVEL | 646.88 | CHUDAKOV | 1 | 1 |  | D |  | EUGENE C |  |  |  | 11-006 | 11-026 |  |  |  | 12-054F |  |  |  |  |  |  |  |  |  |  |  |  |  |  |  |  |  | 07-024 | 08-058 |  |  |  |  |  |  |  |  |  |
| 15222001 |  | Prepare Procurements/Fabrication Packages 2009 (FWD CAL) | 64d | 2009-07-01 | 2009-09-30 | 9-090M FS+184d | 802d | 0d |  | MECH ENG [120 h]; MECH DES [240 h] | 18,178.8 | CHUDAKOV | 1 | 1 |  | D |  | EUGENE C |  |  |  |  | 11-026 |  |  |  | 12-054F |  |  |  |  |  |  | 09-014 |  |  |  |  |  |  |  |  |  |  | 07-024 |  | 2 | 09-027 | 09-027 |  |  |  |  |  |  |
| 15222015 |  | Proc Replacement PMTs (FWD CAL) | 130d | 2009-07-01 | 2010-01-12 | 9-090M FS+184d, 12322018M | 761d | 737d |  | PROCUREMENT<$50K 60 NO ESCALATION FY10; PROCUREMENT>$50K 69 NO ESCALATION FY10 | 85,185.41 | CHUDAKOV | 1 | 1 |  | D |  | EUGENE C |  |  |  |  | 11-026 |  |  |  | 12-054F |  |  |  |  |  |  |  |  |  |  |  |  |  |  |  |  |  |  |  |  |  |  | 08-060 | 09-012 |  |  |  |  |
| 15222003 |  | FY10 Engineering Support for Fabrication (FWD CAL) | 131d | 2009-10-01 | 2010-04-15 | 9-100M | 726d | 300d |  | MECH DES [80 h]; MECH ENG [80 h] | 8,887.2 | CHUDAKOV | 1 | 1 |  | D |  | EUGENE C |  |  |  | 11-006 | 11-026 |  |  |  | 12-054F |  |  |  |  |  |  |  |  |  |  |  |  |  |  |  |  |  | 07-024 |  |  | 09-027 | 09-027 |  |  |  |  |  |  |
| 15222010E |  | FY10 Travel (FWD CAL) | 248d | 2009-10-01 | 2010-09-30 | 15222009E | 317d | 0d |  | TRAVEL | 875.73 | CHUDAKOV | 1 | 1 |  | D |  | EUGENE C |  |  |  | 11-006 | 11-026 |  |  |  | 12-054F |  |  |  |  |  |  |  |  |  |  |  |  |  |  |  |  |  | 07-024 |  |  |  |  |  |  |  |  |  |  |
| 15222025 |  | Setup Divider Constrctn (FWD CAL) (Frozen by CR10-007) | 41d | 2009-10-01 | 2009-11-30 | 9-100M | 207d |  |  | ELEC ENG [328 h] | 21,736.56 | CHUDAKOV | 1 | 1 |  | D | APP | EUGENE C | 5222 |  |  |  |  |  |  |  |  |  |  |  |  |  |  |  |  |  |  |  |  |  |  |  |  |  |  |  |  |  |  | 08-060 |  | 10-007 |  |  |  |
| 15222050 |  | Proc Magnetic Shields (FWD CAL) (Frozen by CR10-007) | 25d | 2009-10-01 | 2009-11-04 | 15222001, 9-100M, 12322018M | 802d | 778d |  | PROCUREMENT<$50K 60 | 61,531.98 | CHUDAKOV | 1 | 1 |  | D | APP | EUGENE C | 5222 |  |  |  | 11-026 |  |  |  | 12-054F |  |  |  |  |  |  |  |  |  |  |  |  |  |  |  |  |  |  |  |  | 09-027 | 09-027 | 08-060 |  | 10-007 |  |  |  |
| 15222045 |  | Setup Procedure & Glue LG to PMT's (FWD CAL) (Frozen by CR10-007) | 10d | 2009-11-12 | 2009-11-25 | 9-100M FS+30d | 787d | 763d |  | CONTRB UNIV LBR [50.4 h]; VISTNG USERS [84 h] | 1,524.6 | CHUDAKOV | 1 | 1 |  | D | APP | EUGENE C | 5222 |  |  |  | 11-026 |  |  |  | 12-054F |  |  |  |  |  |  |  |  |  |  |  |  |  |  |  |  |  |  |  |  |  |  | 08-060 |  | 10-007 |  |  |  |
| 15222110 |  | Reverse Entry Per CR10-007 | 1d | 2009-12-07 | 2009-12-07 | 9-100M FS+45d | 202d |  |  | ELEC ENG [-328 h]; VISTNG USERS [-84 h]; PROCUREMENT<$50K 60; CONTRB UNIV LBR [-50.4 h] | -84,793.14 | CHUDAKOV | 1 | 1 |  | D |  | EUGENE C |  |  |  |  |  |  |  |  |  |  |  |  |  |  |  | 09-014 |  |  |  |  |  |  |  |  |  |  |  |  |  |  |  |  |  | 10-007 |  |  |  |
| 15222002 |  | Prepare Procurements/Fabrication Packages 2010 (FWD CAL) | 64d | 2010-07-01 | 2010-09-30 | 9-100M FS+184d | 609d | 183d |  | MECH ENG [160 h]; MECH DES [400 h] | 28,632 | CHUDAKOV | 1 | 1 |  | D |  | EUGENE C |  |  |  | 11-006 | 11-026 |  |  |  | 12-054F |  |  |  |  |  |  | 09-014 |  |  |  |  |  |  |  |  |  |  | 07-024 |  | 2 | 09-027 | 09-027 |  |  |  |  |  |  |
| 15222011E |  | FY11 Travel (FWD CAL) | 248d | 2010-10-01 | 2011-09-30 | 15222010E | 317d | 0d |  | TRAVEL | 902.21 | CHUDAKOV | 1 | 1 |  | D |  | EUGENE C |  |  |  | 11-006 | 11-026 |  |  |  | 12-054F |  |  |  |  |  |  |  |  |  |  |  |  |  |  |  |  |  | 07-024 |  |  |  |  |  |  | 10-007 |  |  |  |
| 15222007 |  | FY11 Engineering Support for Fabrication (FWD CAL) | 188d | 2011-01-05 | 2011-09-30 | 9-110M FS+60d | 150d | 130d |  | MECH ENG [160 h]; MECH DES [320 h] | 25,809.6 | CHUDAKOV | 1 | 1 |  | D |  | EUGENE C |  |  |  | 11-006 | 11-026 |  |  |  | 12-054F |  |  |  |  |  |  |  |  |  |  |  |  |  |  |  |  |  |  |  | 2 |  |  |  |  |  |  |  |  |
| 15222055 |  | Proc Pb Glass Insert PR | 64d | 2011-02-01 | 2011-05-02 | 9-110M FS+78d | 55d | 0d |  | SCIENTIST [80 h] | 5,474.4 | CHUDAKOV | 1 | 1 |  | D | APP | EUGENE C | 5222 |  |  | 11-006 | 11-026 |  |  |  | 12-054F |  |  |  |  |  |  |  |  |  |  |  |  |  |  |  |  |  |  |  |  | 09-027 | 09-027 | 08-060 |  | 10-007 |  |  |  |
| 15222060 |  | Proc Pb Glass Insert | 269d | 2011-05-03 | 2012-05-31 | 15222055 | 55d | 35d |  |  |  | CHUDAKOV | 1 | 1 |  | D | APP | EUGENE C | 5222 |  |  | 11-006 | 11-026 |  |  |  | 12-054F |  |  |  |  |  |  |  |  |  |  |  |  |  |  |  |  |  |  |  |  | 09-027 | 09-027 | 08-060 |  | 10-007 |  |  |  |
| 15222004 |  | Prep Support Struc Procurement Package 2011(FWD CAL) | 65d | 2011-06-30 | 2011-09-30 | 15222003, 9-110M FS+183d, 15222002 | 426d | 382d |  | MECH ENG [120 h]; MECH DES [160 h] | 15,622.8 | CHUDAKOV | 1 | 1 |  | D |  | EUGENE C |  |  |  | 11-006 | 11-026 |  |  |  | 12-054F |  |  |  |  |  |  |  |  |  |  |  |  |  |  |  |  |  | 07-024 |  |  | 09-027 | 09-027 |  |  |  |  |  |  |
| 15222012E |  | FY12 Travel (FWD CAL) | 58d | 2011-10-03 | 2011-12-30 | 15222011E | 317d | 189d |  | TRAVEL | 187.2 | CHUDAKOV | 1 | 1 |  | D |  | EUGENE C |  |  |  | 11-006 | 11-026 |  |  |  | 12-054F |  |  |  |  |  |  |  |  |  |  |  |  |  |  |  |  |  | 07-024 |  |  |  |  |  |  |  |  |  |  |
| 15222080 |  | Fabricate FCAL Monitoring System (FWD CAL) | 64d | 2012-01-05 | 2012-04-05 | 9-120M FS+60d, 1152055 | 48d | 24d |  | PROCUREMENT<$50K 60; MECH TECH [144 h] | 33,019.8 | CHUDAKOV | 1 | 1 |  | D | APP | EUGENE C | 5222 |  |  | 11-006 | 11-026 |  |  |  | 12-054F |  |  |  |  |  |  |  |  |  |  |  |  |  | 10-042 |  |  |  |  |  |  |  |  | 08-060 | 09-012 |  | 08-016 | 10-002 |  |
| 15222005 |  | FY12 Engineering Support for Fabrication (FWD CAL) | 117d | 2012-04-16 | 2012-09-28 | 9-120M FS+130d, 15222007 | 20d | 0d |  | MECH DES [114.85 h] | 5,532.32 | CHUDAKOV | 1 | 1 |  | D |  | EUGENE C |  |  |  | 11-006 | 11-026 |  |  |  | 12-054F |  |  |  |  |  |  |  |  |  |  |  |  |  |  |  |  |  | 07-024 |  |  | 09-027 | 09-027 |  |  | 10-007 |  |  |  |
| 15222100 |  | Stacking of Blocks (FWD CAL) FY12 | 49d | 2012-07-23 | 2012-09-28 | 15222060, 15222006 FS-253d | 20d | 0d |  | CONTRB UNIV LBR [340.87 h]; MECH TECH [340.87 h] | 15,148.26 | CHUDAKOV | 1 | 1 |  | D |  | EUGENE C |  |  |  | 11-006 | 11-026 |  |  | 12-053 | 12-054F |  |  |  |  |  |  | 09-014 |  |  |  |  |  |  |  |  |  |  |  |  |  |  |  |  |  |  |  |  |  |
| 15222006 |  | FY13 Engineering Support for Fabrication (FWD CAL) | 204d | 2012-10-01 | 2013-07-29 | 15222005 | 20d | 0d |  | MECH ENG [33.95 h]; MECH DES [203.67 h] | 12,581.06 | CHUDAKOV | 1 | 1 |  | D |  | EUGENE C |  |  |  | 11-006 | 11-026 |  |  |  | 12-054F |  |  |  |  |  |  | 09-014 |  |  |  |  |  |  |  |  |  |  | 07-024 |  | 2 | 09-027 | 09-027 |  |  | 10-007 |  |  |  |
| 15222100a |  | Stacking of Blocks (FWD CAL) FY13 | 204d | 2012-10-01 | 2013-07-29 | 15222100 | 20d | 0d |  | CONTRB UNIV LBR [1419.13 h]; MECH TECH [1419.13 h] | 65,081.3 | CHUDAKOV | 1 | 1 |  | D |  | EUGENE C |  |  |  | 11-006 | 11-026 |  |  | 12-053 | 12-054F |  |  |  |  |  |  | 09-014 |  |  |  |  |  |  |  |  |  |  |  |  |  |  |  |  |  |  |  |  |  |
| 15222105 |  | Assy of Single Channel FCal Detector (FWD CAL) | 65d | 2013-01-03 | 2013-04-05 | 15222050, 195222285, 15222045, 9-130M FS+60d, 15222015, 15222080 FS+159d | 24d | 0d |  | MECH TECH [880 h]; CONTRB UNIV LBR [1760 h] | 40,356.8 | CHUDAKOV | 1 | 1 |  | D |  | EUGENE C |  |  |  | 11-006 | 11-026 |  |  |  | 12-054 |  |  |  |  |  |  | 09-014 |  |  |  |  |  |  | 10-042 |  |  |  |  |  |  |  |  |  |  | 10-007 |  |  | 10-009 |
| 15222115 |  | Re-Baseline Actuals Adjustment | 1d | 2013-08-30 | 2013-08-30 | 9-130M FS+227d | 20d |  |  | PROCUREMENT>$50K 69 NO ESCALATION | -95,164.67 | CHUDAKOV | 1 | 1 |  |  |  | EUGENE C |  |  |  |  |  |  |  |  |  |  | 13-014 | ADJ |  |  |  |  |  |  |  |  |  |  |  |  |  |  |  |  |  |  |  |  |  |  |  |  |  |
| 25222085 |  | Fabricate and Install Monitoring Panes (FCAL) FY13 | 20d | 2013-09-03 | 2013-09-30 | 9-130M FS+228d | 79d | 0d | 8/5 M-F w/JLAB Holidays ReBaseline | SCIENTIST [27.27 h]; MECH ENG [4.55 h]; MECH DES [9.09 h]; SUPPLIES & MATERIALS; MECH TECH [36.36 h] | 4,999.03 | CHUDAKOV | 1 | 1 |  | D | APP | EUGENE C | 5222 |  |  | 11-006 | 11-026 |  |  |  | 12-054F |  |  |  | 25222085 |  | S |  |  | 13-007 |  | 13-015 | PR |  | 10-042 | EJ | EJ |  |  |  |  |  |  | 08-060 | 09-012 |  | 08-016 | 10-002 |  |
| 25222090 |  | Fabricate and Install Monitoring Panes (FCAL) (Previously Obligated) | 88d | 2013-09-03 | 2014-01-16 | 9-130M FS+228d | 79d | 0d | 8/5 M-F w/JLAB Holidays ReBaseline | PROCUREMENT<$50K 60 NO ESCALATION FY14 | 5,520 | CHUDAKOV | 1 | 1 |  | D | APP | EUGENE C | 5222 |  |  | 11-006 | 11-026 |  |  |  | 12-054F |  |  |  | 25222085 | y | S |  |  | 13-007 |  | 13-015 | PR | OB | 10-042 | EJ | EJ |  |  |  |  |  |  | 08-060 | 09-012 |  | 08-016 | 10-002 |  |
| 25222085a |  | Fabricate and Install Monitoring Panes (FCAL) FY14 | 68d | 2013-10-01 | 2014-01-16 | 25222085, 9-130M FS+228d | 79d | 0d | 8/5 M-F w/JLAB Holidays ReBaseline | SCIENTIST [92.72 h]; MECH ENG [15.45 h]; MECH DES [30.91 h]; SUPPLIES & MATERIALS; MECH TECH [123.63 h] | 17,538.39 | CHUDAKOV | 1 | 1 |  | D | APP | EUGENE C | 5222 |  |  | 11-006 | 11-026 |  |  |  | 12-054F |  |  |  | 25222085 |  | S |  |  | 13-007 |  | 13-015 | PR |  | 10-042 | EJ | EJ | 14-001 |  |  |  |  |  | 08-060 | 09-012 |  | 08-016 | 10-002 |  |

Notes:
- 15221161s: Explanation: IPL from 6 GeV 55221010 and 55221010c

| ID | WBS | Activity | Duration | Start | Finish | Predecessors | Total float | Free float | Calendar | Resources | Cost | RESP - Responsibility | STRT%COMP for CM EVM | FNSH%COMP for CM EVM | HALL D Related Milestones | CAM RESPONSIBLE | CR 10-042 | CR 11-026 | CR 12-021 | CR 12-049 | CR 07-024 | 12 GeV 2nd level Critical Path | CR 09-014 | CR 09-027 | CR 09-027 Repair | CR 11-006 | CR 12-054 | CR 09-012 | CR 12-053 | CR 13-014 | ReBaseline Actuals Adjustment | Original Activity ID Rebaseline | EVMS Reporting Codes | CR 13-007 | BOE Labor | CR 13-015 | Post Rebaseline | Over Under Fixed | BOE Procurement | Obligated Prior to Rebaseline | CR 14-001 |
| --- | --- | --- | --- | --- | --- | --- | --- | --- | --- | --- | --- | --- | --- | --- | --- | --- | --- | --- | --- | --- | --- | --- | --- | --- | --- | --- | --- | --- | --- | --- | --- | --- | --- | --- | --- | --- | --- | --- | --- | --- | --- |
|  | 3 | **1.5.2.2.3 UPSTREAM PHOTON VETO** |  |  |  |  |  |  |  |  |  |  |  |  |  |  |  |  |  |  |  |  |  |  |  |  |  |  |  |  |  |  |  |  |  |  |  |  |  |  |  |
|  | 3 | **1.5.2.3 PARTICLE ID** |  | 2010-08-02 | 2014-01-31 |  |  |  |  |  |  |  |  |  |  |  |  |  |  |  |  |  |  |  |  |  |  |  |  |  |  |  |  |  |  |  |  |  |  |  |  |
|  | 1 | **1.5.2.3.1 TIME OF FLIGHT** |  | 2010-08-02 | 2014-01-31 |  |  |  |  |  |  |  |  |  |  |  |  |  |  |  |  |  |  |  |  |  |  |  |  |  |  |  |  |  |  |  |  |  |  |  |  |
| 15231019 |  | Proc First Article PMTs (TOF) | 43d | 2010-08-02 | 2010-09-30 | 9-100M FS+205d | 743d | 495d |  | PROCUREMENT<$50K 60 | 12,000 | CHUDAKOV | 1 | 1 | D | EUGENE C | 10-042 | 11-026 | 12-021F | 12-049F |  |  |  |  |  |  |  |  |  |  |  |  |  |  |  |  |  |  |  |  |  |
| 15231011E |  | FY11 Travel (TOF) | 248d | 2010-10-01 | 2011-09-30 | 9-110M | 128d | 0d |  | TRAVEL | 1,606.65 | CHUDAKOV | 1 | 1 | D | EUGENE C |  | 11-026 |  |  | 07-024 |  |  |  |  |  |  |  |  |  |  |  |  |  |  |  |  |  |  |  |  |
| 15231001 |  | Prepare Procurements/Fabrication Packages 2011 (TOF) | 86d | 2011-06-01 | 2011-09-30 | 9-110M FS+162d | 288d | 0d |  | MECH ENG [40 h]; MECH DES [760 h] | 38,194.8 | CHUDAKOV | 1 | 1 | D | EUGENE C |  | 11-026 | 12-021F | 12-049F | 07-024 | 2 | 09-014 | 09-027 | 09-027 | 11-006 | 12-054F |  |  |  |  |  |  |  |  |  |  |  |  |  |  |
| 15231001a |  | Prepare Procurements/Fabrication Packages 2012 (TOF) | 127d | 2011-10-03 | 2012-04-10 | 15231001 | 288d | 180d |  | MECH DES [760 h]; MECH ENG [40 h] | 39,414 | CHUDAKOV | 1 | 1 | D | EUGENE C |  | 11-026 | 12-021F | 12-049F | 07-024 | 2 | 09-014 | 09-027 | 09-027 | 11-006 | 12-054F |  |  |  |  |  |  |  |  |  |  |  |  |  |  |
| 15231012E |  | FY12 Travel (TOF) | 247d | 2011-10-03 | 2012-09-28 | 15231011E | 128d | 0d |  | TRAVEL | 1,657.9 | CHUDAKOV | 1 | 1 | D | EUGENE C |  | 11-026 |  |  | 07-024 |  |  |  |  |  |  |  |  |  |  |  |  |  |  |  |  |  |  |  |  |
| 15231015 |  | FSU - Proc Supplies (TOF) Part A | 20d | 2011-11-02 | 2011-12-01 | 9-120M FS+22d, 12323040M | 453d |  |  | PROCUREMENT>$50K 69 | 11,700.06 | CHUDAKOV | 1 | 1 | D | EUGENE C |  | 11-026 | 12-021F | 12-049 |  |  |  |  |  |  |  |  |  |  |  |  |  |  |  |  |  |  |  |  |  |
| 15231020 |  | Proc PMTs (TOF) | 124d | 2012-04-05 | 2012-09-28 | 9-120M FS+123d, 12323040M, 15231019 FF | 248d |  |  | PROCUREMENT<$50K 60; PROCUREMENT>$50K 69 | 147,828.89 | CHUDAKOV | 1 | 1 | D | EUGENE C | 10-042 | 11-026 | 12-021 | 12-049F |  |  |  |  |  |  |  |  |  |  |  |  |  |  |  |  |  |  |  |  |  |
| 15231025 |  | Proc Dividers (TOF) | 124d | 2012-04-05 | 2012-09-28 | 9-120M FS+123d, 12323040M | 248d |  |  | PROCUREMENT<$50K 60 | 31,385.4 | CHUDAKOV | 1 | 1 | D | EUGENE C |  | 11-026 | 12-021 | 12-049F |  |  |  |  |  |  |  | 09-012 |  |  |  |  |  |  |  |  |  |  |  |  |  |
| 15231002 |  | Engineering Support for Testing 2012 | 65d | 2012-05-29 | 2012-08-28 | 9-120M FS+160d | 270d |  |  | MECH DES [80 h]; MECH ENG [80 h] | 9,463.2 | CHUDAKOV | 1 | 1 | D | EUGENE C |  | 11-026 | 12-021F | 12-049F | 07-024 | 2 | 09-014 | 09-027 | 09-027 |  | 12-054F |  |  |  |  |  |  |  |  |  |  |  |  |  |  |
| 15231070 |  | FSU - Scintillator Procurement Part D | 38d | 2012-07-11 | 2012-08-31 | 9-120M FS+190d | 267d |  |  | PROCUREMENT<$50K 60 NO ESCALATION | 5,489.28 | CHUDAKOV | 1 | 1 | D | EUGENE C |  | 11-026 | 12-021 | 12-049 |  |  |  |  |  |  |  |  | 12-053 |  |  |  |  |  |  |  |  |  |  |  |  |
| 15231060 |  | FSU - Scintillator Procurement Part B | 31d | 2012-07-20 | 2012-08-31 | 9-120M FS+197d | 267d |  |  | PROCUREMENT<$50K 60 NO ESCALATION | 2,745.98 | CHUDAKOV | 1 | 1 | D | EUGENE C |  | 11-026 | 12-021 | 12-049 |  |  |  |  |  |  |  |  | 12-053 |  |  |  |  |  |  |  |  |  |  |  |  |
| 15231065 |  | FSU - Scintillator Procurement Part C | 26d | 2012-07-27 | 2012-08-31 | 9-120M FS+202d | 267d |  |  | PROCUREMENT<$50K 60 NO ESCALATION | 3,051.62 | CHUDAKOV | 1 | 1 | D | EUGENE C |  | 11-026 | 12-021 | 12-049 |  |  |  |  |  |  |  |  | 12-053 |  |  |  |  |  |  |  |  |  |  |  |  |
| 15231055 |  | FSU - Scintillator Procurement Part A | 1d | 2012-08-31 | 2012-08-31 | 9-120M FS+227d | 267d |  |  | PROCUREMENT<$50K 60 NO ESCALATION | 284.53 | CHUDAKOV | 1 | 1 | D | EUGENE C |  | 11-026 | 12-021 | 12-049 |  |  |  |  |  |  |  |  | 12-053 |  |  |  |  |  |  |  |  |  |  |  |  |
| 15231075 |  | FSU - Scintillator Procurement Part E | 225d | 2012-09-04 | 2013-07-31 | 1152055, 9-120M FS+228d | 20d | 0d |  | PROCUREMENT<$50K 60 NO ESCALATION; PROCUREMENT>$50K 69 NO ESCALATION | 75,648.59 | CHUDAKOV | 1 | 1 | D | EUGENE C |  | 11-026 | 12-021 | 12-049 |  |  |  | 09-027 | 09-027 | 11-006 |  |  |  |  |  |  |  |  |  |  |  |  |  |  |  |
| 15231080 |  | FSU - Light Guide Material Procurement | 225d | 2012-09-04 | 2013-07-31 | 15231075 FS-225d | 20d | 0d |  | PROCUREMENT>$50K 69 NO ESCALATION | 17,856 | CHUDAKOV | 1 | 1 | D | EUGENE C |  | 11-026 | 12-021 | 12-049 |  |  |  | 09-027 | 09-027 | 11-006 |  |  |  |  |  |  |  |  |  |  |  |  |  |  |  |
| 15231090 |  | FSU - Proc Supplies (TOF) Part B | 225d | 2012-09-04 | 2013-07-31 | 15231080 FS-225d | 20d | 0d |  | PROCUREMENT>$50K 69 NO ESCALATION | 9,784.94 | CHUDAKOV | 1 | 1 | D | EUGENE C |  | 11-026 | 12-021 | 12-049 |  |  |  |  |  | 11-006 |  |  |  |  |  |  |  |  |  |  |  |  |  |  |  |
| 15231093 |  | FSU - Jig Construction | 62d | 2012-09-04 | 2012-11-30 | 15231090 FS-225d | 20d | 0d |  | PROCUREMENT>$50K 69 NO ESCALATION | 18,523.51 | CHUDAKOV | 1 | 1 | D | EUGENE C |  |  |  | 12-049 |  |  |  |  |  |  |  |  |  |  |  |  |  |  |  |  |  |  |  |  |  |
| 15231095 |  | FSU - Polishing and Gluing of First 30 Units | 183d | 2012-09-04 | 2013-05-31 | 15231093 FS-62d | 20d | 0d |  | PROCUREMENT>$50K 69 NO ESCALATION | 16,382.87 | CHUDAKOV | 1 | 1 | D | EUGENE C |  |  |  | 12-049 |  |  |  |  |  |  |  |  |  |  |  |  |  |  |  |  |  |  |  |  |  |
| 15231100 |  | FSU - Wrapping of First 30 Units | 183d | 2012-09-04 | 2013-05-31 | 15231095 FS-183d | 20d | 0d |  | PROCUREMENT>$50K 69 NO ESCALATION | 9,014.5 | CHUDAKOV | 1 | 1 | D | EUGENE C |  |  |  | 12-049 |  |  |  |  |  |  |  |  |  |  |  |  |  |  |  |  |  |  |  |  |  |
| 15231105 |  | FSU - Mount PMT and Testing of First 30 Units | 183d | 2012-09-04 | 2013-05-31 | 15231100 FS-183d | 20d | 0d |  | PROCUREMENT>$50K 69 NO ESCALATION | 18,739.86 | CHUDAKOV | 1 | 1 | D | EUGENE C |  |  |  | 12-049 |  |  |  |  |  |  |  |  |  |  |  |  |  |  |  |  |  |  |  |  |  |
| 15231110 |  | FSU - Polishing and Gluing of Second 30 Units | 247d | 2012-09-04 | 2013-08-30 | 15231105 FS-183d | 20d | 0d |  | PROCUREMENT>$50K 69 NO ESCALATION | 16,382.87 | CHUDAKOV | 1 | 1 | D | EUGENE C |  |  |  | 12-049 |  |  |  |  |  |  |  |  |  |  |  |  |  |  |  |  |  |  |  |  |  |
| 15231115 |  | FSU - Wrapping of Second 30 Units | 247d | 2012-09-04 | 2013-08-30 | 15231110 FS-247d | 20d | 0d |  | PROCUREMENT>$50K 69 NO ESCALATION | 9,014.5 | CHUDAKOV | 1 | 1 | D | EUGENE C |  |  |  | 12-049 |  |  |  |  |  |  |  |  |  |  |  |  |  |  |  |  |  |  |  |  |  |
| 15231120 |  | FSU - Mount PMT and Testing of Second 30 Units | 247d | 2012-09-04 | 2013-08-30 | 15231115 FS-247d | 20d |  |  | PROCUREMENT>$50K 69 NO ESCALATION | 18,739.86 | CHUDAKOV | 1 | 1 | D | EUGENE C |  |  |  | 12-049 |  |  |  |  |  |  |  |  |  |  |  |  |  |  |  |  |  |  |  |  |  |
| 15231013E |  | FY13 Travel (TOF) | 120d | 2012-10-01 | 2013-03-29 | 15222012E, 15231012E | 128d |  |  | TRAVEL | 683.36 | CHUDAKOV | 1 | 1 | D | EUGENE C |  | 11-026 |  |  | 07-024 |  |  |  |  |  |  |  |  |  |  |  |  |  |  |  |  |  |  |  |  |
| 15231030 |  | Proc Magnetic Shields (TOF) | 80d | 2013-01-03 | 2013-04-26 | 9-130M FS+60d, 15231001a, 12323040M | 108d |  |  | PROCUREMENT>$50K 69 | 11,358.55 | CHUDAKOV | 1 | 1 | D | EUGENE C |  | 11-026 | 12-021 |  |  |  |  | 09-027 | 09-027 | 11-006 |  |  |  |  |  |  |  |  |  |  |  |  |  |  |  |
| 15231045 |  | Proc Supprt Struct (TOF) | 40d | 2013-02-01 | 2013-03-29 | 9-130M FS+80d, 9-120M FS+22d, 15231001a, 12323040M | 128d |  |  | PROCUREMENT<$50K 60 | 24,146.57 | CHUDAKOV | 1 | 1 | D | EUGENE C |  | 11-026 | 12-021F |  |  |  |  | 09-027 | 09-027 | 11-006 |  |  |  |  |  |  |  |  |  |  |  |  |  |  |  |
| 15231150 |  | Re-Baseline Actuals Adjustment | 1d | 2013-08-30 | 2013-08-30 | 9-130M FS+227d | 20d |  |  | PROCUREMENT>$50K 69 NO ESCALATION | -66,828.86 | CHUDAKOV | 1 | 1 |  | EUGENE C |  |  |  |  |  |  |  |  |  |  |  |  |  | 13-014 | ADJ |  |  |  |  |  |  |  |  |  |  |
| 25231010 |  | FSU contract support and supervision FY13 | 20d | 2013-09-03 | 2013-09-30 | 9-130M FS+228d | 269d | 0d | 8/5 M-F w/JLAB Holidays ReBaseline | SCIENTIST [35.4 h]; MECH DES [8.6 h]; MECH ENG [4.3 h] | 3,318.53 | CHUDAKOV | 1 | 1 | D | EUGENE C |  | 11-026 | 12-021 | 12-049 |  |  |  |  |  |  |  |  |  |  |  | 25231010 | E | 13-007 | PE | 13-015 | PR |  |  |  |  |
| 25231085 |  | FSU - Initial wrapping and fitup | 20d | 2013-09-03 | 2013-09-30 | 9-130M FS+228d | 111d | 42d | 8/5 M-F w/JLAB Holidays ReBaseline | PROCUREMENT<$50K 60 NO ESCALATION; PROCUREMENT>$50K 69 NO ESCALATION | 179,568.62 | CHUDAKOV | 1 | 1 | D | EUGENE C |  | 11-026 | 12-021 | 12-049 |  |  |  |  |  | 11-006 |  |  |  |  |  | 25231090 | D | 13-007F |  | 13-015 | PR | y | OB | OB |  |
| 25231090 |  | FSU - Proc Supplies (TOF) | 20d | 2013-09-03 | 2013-09-30 | 9-130M FS+228d | 111d | 42d | 8/5 M-F w/JLAB Holidays ReBaseline | PROCUREMENT>$50K 69 NO ESCALATION | 2,363.35 | CHUDAKOV | 1 | 1 | D | EUGENE C |  | 11-026 | 12-021 | 12-049 |  |  |  |  |  | 11-006 |  |  |  |  |  | 25231090 | D | 13-007F |  | 13-015 | PR | y | OB | OB |  |
| 25231105 |  | FSU - Mount PMT and Testing of First 30 Units | 20d | 2013-09-03 | 2013-09-30 | 9-130M FS+228d | 69d | 0d | 8/5 M-F w/JLAB Holidays ReBaseline | PROCUREMENT>$50K 69 NO ESCALATION | 7,683.34 | CHUDAKOV | 1 | 1 | D | EUGENE C |  |  |  | 12-049 |  |  |  |  |  |  |  |  |  |  |  | 25231105 | D | 13-007F |  | 13-015 | PR | y | OB | OB |  |
| 25231115 |  | FSU - Wrapping of Second 30 Units | 20d | 2013-09-03 | 2013-09-30 | 25231105 FS-20d | 69d | 0d | 8/5 M-F w/JLAB Holidays ReBaseline | PROCUREMENT>$50K 69 NO ESCALATION | 450.73 | CHUDAKOV | 1 | 1 | D | EUGENE C |  |  |  | 12-049 |  |  |  |  |  |  |  |  |  |  |  | 25231115 | D | 13-007F |  | 13-015 | PR | y | OB | OB |  |
| 25231120 |  | FSU - Mount PMT and Testing of Second 30 Units | 20d | 2013-09-03 | 2013-09-30 | 25231115 FS-20d | 69d | 0d | 8/5 M-F w/JLAB Holidays ReBaseline | PROCUREMENT>$50K 69 NO ESCALATION | 9,369.93 | CHUDAKOV | 1 | 1 | D | EUGENE C |  |  |  | 12-049 |  |  |  |  |  |  |  |  |  |  |  | 25231120 | D | 13-007F |  | 13-015 | PR | y | OB | OB |  |
| 25231125 |  | FSU - Polishing and Gluing of Third 30 Units | 43d | 2013-09-03 | 2013-10-31 | 25231120 FS-20d | 69d | 0d | 8/5 M-F w/JLAB Holidays ReBaseline | PROCUREMENT>$50K 69 NO ESCALATION | 1,146.8 | CHUDAKOV | 1 | 1 | D | EUGENE C |  |  |  | 12-049 |  |  |  |  |  |  |  |  |  |  |  | 25231125 | D | 13-007F |  | 13-015 | PR | y | OB | OB |  |
| 25231130 |  | FSU - Wrapping of Third 30 Units | 43d | 2013-09-03 | 2013-10-31 | 25231125 FS-43d | 69d | 0d | 8/5 M-F w/JLAB Holidays ReBaseline | PROCUREMENT>$50K 69 NO ESCALATION | 9,014.5 | CHUDAKOV | 1 | 1 | D | EUGENE C |  |  |  | 12-049 |  |  |  |  |  |  |  |  |  |  |  | 25231130 | D | 13-007F |  | 13-015 | PR | y | OB | OB |  |
| 25231135 |  | FSU - Mount PMT and Testing of Third 30 Units | 43d | 2013-09-03 | 2013-10-31 | 25231130 FS-43d | 69d | 0d | 8/5 M-F w/JLAB Holidays ReBaseline | PROCUREMENT>$50K 69 NO ESCALATION | 14,054.9 | CHUDAKOV | 1 | 1 | D | EUGENE C |  |  |  | 12-049 |  |  |  |  |  |  |  |  |  |  |  | 25231135 | D | 13-007F |  | 13-015 | PR | y | OB | OB |  |
| 25231140 |  | FSU - Construction Manager | 62d | 2013-09-03 | 2013-11-27 | 25231135 FS-43d | 69d | 0d | 8/5 M-F w/JLAB Holidays ReBaseline | PROCUREMENT>$50K 69 NO ESCALATION | 21,380.59 | CHUDAKOV | 1 | 1 | D | EUGENE C |  |  |  | 12-049 |  |  |  |  |  |  |  |  |  |  |  | 25231140 | E | 13-007F |  | 13-015 | PR | y | OB | OB |  |
| 25231145 |  | FSU - Shipping of TOF | 77d | 2013-09-03 | 2013-12-20 | 25231140 FS-62d | 69d | 0d | 8/5 M-F w/JLAB Holidays ReBaseline | PROCUREMENT>$50K 69 NO ESCALATION | 11,939.51 | CHUDAKOV | 1 | 1 | D | EUGENE C |  |  |  | 12-049 |  |  |  |  |  |  |  |  |  |  |  | 25231145 | D | 13-007F |  | 13-015 | PR | y | OB | OB |  |
| 25231010a |  | FSU contract support and supervision FY14 | 42d | 2013-10-01 | 2013-11-27 | 25231010, 9-130M FS+228d | 269d | 200d | 8/5 M-F w/JLAB Holidays ReBaseline | SCIENTIST [65.5 h]; MECH DES [15.92 h]; MECH ENG [7.96 h] | 6,334.7 | CHUDAKOV | 1 | 1 | D | EUGENE C |  | 11-026 | 12-021 | 12-049 |  |  |  |  |  |  |  |  |  |  |  | 25231010 | E | 13-007 | PE | 13-015 | PR |  |  |  | 14-001 |
| 25231030 |  | Proc Magnetic Shields (TOF) | 34d | 2013-11-01 | 2013-12-20 | 9-140M FS+23d | 84d | 21d | 8/5 M-F w/JLAB Holidays ReBaseline | PROCUREMENT>$50K 69 | 5,860.44 | CHUDAKOV | 1 | 1 | D | EUGENE C |  | 11-026 | 12-021 |  |  |  |  | 09-027 | 09-027 | 11-006 |  |  |  |  |  | 25231030 | D | 13-007 |  | 13-015 | PR |  | PE |  | 14-001 |
| 25231045 |  | Proc Supprt Struct (TOF) | 47d | 2013-11-13 | 2014-01-31 | 9-140M FS+31d, 9-130M FS+228d | 63d | 0d | 8/5 M-F w/JLAB Holidays ReBaseline | PROCUREMENT<$50K 60 | 22,425.16 | CHUDAKOV | 1 | 1 | D | EUGENE C |  | 11-026 | 12-021F |  |  |  |  | 09-027 | 09-027 | 11-006 |  |  |  |  |  | 25231045 | D | 13-007 |  | 13-015 | PR |  | PE |  | 14-001 |

| ID | WBS | Activity | Duration | Start | Finish | Predecessors | Total float | Free float | Resources | Cost | RESP - Responsibility | STRT%COMP for CM EVM | FNSH%COMP for CM EVM | HALL D Related Milestones | CR 07-024 | CAM RESPONSIBLE | CR 11-026 | CR 10-042 | CR 11-006 | CR 12-021 | CR 07-027 | Profile change | Advance Purchase Plan > 500K | CR 08-016 | 12 GEV MAJOR PROCUREMENT CATAGORY | CR 09-012 | CR 12-054 | CR 12-001 | CR 12-055 | CR 12-053 | CR 08-052 |
| --- | --- | --- | --- | --- | --- | --- | --- | --- | --- | --- | --- | --- | --- | --- | --- | --- | --- | --- | --- | --- | --- | --- | --- | --- | --- | --- | --- | --- | --- | --- | --- |
|  | 2 | **1.5.2.3.2 CERENKOV COUNTER** |  |  |  |  |  |  |  |  |  |  |  |  |  |  |  |  |  |  |  |  |  |  |  |  |  |  |  |  |  |
|  | 3 | **1.5.3 COMPUTING** |  | 2010-10-01 | 2014-12-11 |  |  |  |  |  |  |  |  |  |  |  |  |  |  |  |  |  |  |  |  |  |  |  |  |  |  |
|  | 1 | **1.5.3.1 DAQ** |  | 2010-10-01 | 2014-12-11 |  |  |  |  |  |  |  |  |  |  |  |  |  |  |  |  |  |  |  |  |  |  |  |  |  |  |
| 15311011E |  | FY11 Travel (DAQ) | 248d | 2010-10-01 | 2011-09-30 | 9-110M | 189d | 0d | TRAVEL | 883.25 | CHUDAKOV | 1 | 1 | D | 07-024 | EUGENE C | 11-026 |  |  |  |  |  |  |  |  |  |  |  |  |  |  |
| 1531170 |  | Software Licenses and Fees FY11 | 189d | 2011-01-04 | 2011-09-30 | 9-110M FS+59d | 251d | 0d | PROCUREMENT<$50K 60 | 8,000 | CHUDAKOV | 1 | 1 | D |  | EUGENE C | 11-026 | 10-042 | 11-006 | 12-021F |  |  |  |  |  |  |  |  |  |  |  |
| 1531200 |  | Proc PLC comm Modules PR | 22d | 2011-02-01 | 2011-03-03 | 9-110M FS+78d | 303d | 0d | SCIENTIST [40 h] | 2,737.2 | CHUDAKOV | 1 | 1 | D |  | EUGENE C | 11-026 | 10-042 | 11-006 | 12-021F |  |  |  |  |  |  |  |  |  |  |  |
| 1531230 |  | Proc PLC Controller PR | 22d | 2011-02-01 | 2011-03-03 | 9-110M FS+78d | 231d | 0d | SCIENTIST [40 h] | 2,737.2 | CHUDAKOV | 1 | 1 | D |  | EUGENE C | 11-026 | 10-042 | 11-006 | 12-021 |  |  |  |  |  |  |  |  |  |  |  |
| 1531205 |  | Proc PLC comm Modules | 63d | 2011-03-04 | 2011-06-01 | 1531200 | 303d | 162d | PROCUREMENT<$50K 60 | 4,000 | CHUDAKOV | 1 | 1 | D |  | EUGENE C | 11-026 | 10-042 | 11-006 | 12-021F |  |  |  |  |  |  |  |  |  |  |  |
| 1531235 |  | Proc PLC Controller | 42d | 2011-03-04 | 2011-05-02 | 1531230 | 231d | 0d | PROCUREMENT<$50K 60 | 6,000 | CHUDAKOV | 1 | 1 | D |  | EUGENE C | 11-026 | 10-042 | 11-006 |  |  |  |  |  |  |  |  |  |  |  |  |
| 1531005 |  | Proc Single Board Computing PR (DAQ) | 43d | 2011-04-01 | 2011-06-01 | 1233040M, 9-110M FS+120d | 314d | 0d | SCIENTIST [40 h] | 2,737.2 | CHUDAKOV | 1 | 1 | D | 07-024 | EUGENE C | 11-026 |  | 11-006 | 12-021F | 07-027 | C | APP | 08-016 | 531 | 09-012 | 12-054F |  |  |  |  |
| 1531180 |  | Proc embedded computers for controls PR | 22d | 2011-04-01 | 2011-05-02 | 9-110M FS+120d | 241d | 0d | SCIENTIST [40 h] | 2,737.2 | CHUDAKOV | 1 | 1 | D |  | EUGENE C | 11-026 | 10-042 | 11-006 | 12-021F |  |  |  |  |  |  |  |  |  |  |  |
| 1531185 |  | Proc embedded computers for controls | 83d | 2011-05-03 | 2011-08-29 | 1531180 | 241d | 100d | PROCUREMENT<$50K 60 | 1,000 | CHUDAKOV | 1 | 1 | D |  | EUGENE C | 11-026 | 10-042 | 11-006 | 12-021F |  |  |  |  |  |  |  |  |  |  |  |
| 1531240 |  | Install PLC Controller | 43d | 2011-05-03 | 2011-07-01 | 1531235 | 231d | 183d | SCIENTIST [40 h] | 2,737.2 | CHUDAKOV | 1 | 1 | D |  | EUGENE C | 11-026 | 10-042 | 11-006 |  |  |  |  |  |  |  |  |  |  |  |  |
| 1531005a |  | Proc Single Board Computing First items (DAQ) | 65d | 2011-06-02 | 2011-09-01 | 1531005 | 314d | 0d | PROCUREMENT<$50K 60 | 20,000 | CHUDAKOV | 1 | 1 | D |  | EUGENE C | 11-026 |  | 11-006 | 12-021F |  |  | APP |  | 531 |  | 12-054F |  |  |  |  |
| 1531080 |  | Proc Racks (DAQ) PR | 44d | 2011-08-01 | 2011-09-30 | 9-110M FS+204d | 377d | 0d | SCIENTIST [40 h] | 2,737.2 | CHUDAKOV | 1 | 1 | D | 07-024 | EUGENE C | 11-026 |  | 11-006 | 12-021F | 07-027 |  | APP |  | 531 |  | 12-054F |  |  |  |  |
| 1531005b |  | Proc Single Board Computing Test First items (DAQ) FY11 | 20d | 2011-09-02 | 2011-09-30 | 1531005a | 314d | 0d | SCIENTIST [27.35 h] | 1,871.56 | CHUDAKOV | 1 | 1 | D |  | EUGENE C | 11-026 |  | 11-006 | 12-021F |  |  | APP |  | 531 |  | 12-054F | 12-001 |  |  |  |
| 1531005ba |  | Proc Single Board Computing Test First items (DAQ) FY12 | 97d | 2011-10-03 | 2012-02-28 | 1531005b | 314d | 0d | SCIENTIST [132.65 h] | 9,366.42 | CHUDAKOV | 1 | 1 | D |  | EUGENE C | 11-026 |  | 11-006 | 12-021F |  |  | APP |  | 531 |  | 12-054F | 12-001 |  |  |  |
| 1531020 |  | Proc EB nodes (DAQ) PR | 41d | 2011-10-03 | 2011-11-30 | 9-120M | 354d | 286d | COMP SCIENT [40 h]; SCIENTIST [40 h] | 5,449.2 | CHUDAKOV | 1 | 1 | D |  | EUGENE C | 11-026 |  | 11-006 | 12-021F |  |  | APP |  | 531 |  | 12-054F |  |  |  |  |
| 1531065 |  | Proc Cables (DAQ) PR | 42d | 2011-10-03 | 2011-12-01 | 9-120M | 291d | 245d | SCIENTIST [80 h] | 5,648.8 | CHUDAKOV | 1 | 1 | D |  | EUGENE C | 11-026 |  | 11-006 | 12-021F |  |  | APP |  | 531 |  | 12-054F |  |  |  |  |
| 1531082 |  | Proc Racks (DAQ) | 78d | 2011-10-03 | 2012-01-31 | 1531080 | 377d | 353d | PROCUREMENT<$50K 60 | 26,829.4 | CHUDAKOV | 1 | 1 | D | 07-024 | EUGENE C | 11-026 |  | 11-006 | 12-021F | 07-027 |  | APP |  | 531 |  | 12-054F |  |  |  |  |
| 1531090 |  | Proc Test Setup Equipmnt (DAQ) PR | 77d | 2011-10-03 | 2012-01-30 | 1233040M, 9-120M | 230d | 64d | SCIENTIST [80 h] | 5,648.8 | CHUDAKOV | 1 | 1 | D |  | EUGENE C | 11-026 |  | 11-006 | 12-021F |  |  | APP |  | 531 |  |  |  |  |  |  |
| 15311012E |  | FY12 Travel (DAQ) | 247d | 2011-10-03 | 2012-09-28 | 15311011E | 189d | 0d | TRAVEL | 1,547.85 | CHUDAKOV | 1 | 1 | D | 07-024 | EUGENE C | 11-026 |  | 11-006 |  |  |  |  |  |  |  |  |  |  |  |  |
| 1531155 |  | Proc VME based electronic for Controls/Monitoring PR | 41d | 2011-10-03 | 2011-11-30 | 9-120M | 142d | 122d | SCIENTIST [80 h] | 5,648.8 | CHUDAKOV | 1 | 1 | D |  | EUGENE C | 11-026 | 10-042 | 11-006 | 12-021F |  |  |  |  |  |  |  |  |  |  |  |
| 1531175 |  | Software Licenses and Fees FY12 | 244d | 2011-10-03 | 2012-09-25 | 1531170, 9-120M | 251d |  | PROCUREMENT<$50K 60 | 4,127.6 | CHUDAKOV | 1 | 1 | D |  | EUGENE C | 11-026 | 10-042 | 11-006 | 12-021F |  |  |  |  |  |  |  |  |  |  |  |
| 1531210 |  | Proc PLC Point I/O Chassis PR | 21d | 2011-10-03 | 2011-10-31 | 9-120M | 105d | 0d | SCIENTIST [40 h] | 2,824.4 | CHUDAKOV | 1 | 1 | D |  | EUGENE C | 11-026 | 10-042 | 11-006 | 12-021F |  |  |  |  |  |  |  |  |  |  |  |
| 1531093 |  | Plan Installation in Counting House | 77d | 2011-10-31 | 2012-02-28 | 9-120M FS+20d | 230d | 210d | SCIENTIST [80 h]; ELEC TECH [80 h] | 9,179.2 | CHUDAKOV | 1 | 1 | D |  | EUGENE C | 11-026 |  | 11-006 | 12-021F |  |  | APP |  | 531 |  |  |  |  |  |  |
| 1531215 |  | Proc PLC Point I/O Chassis | 56d | 2011-11-01 | 2012-01-30 | 1531210 | 105d | 0d | PROCUREMENT<$50K 60 | 3,095.7 | CHUDAKOV | 1 | 1 | D |  | EUGENE C | 11-026 | 10-042 | 11-006 | 12-021F |  |  |  |  |  |  |  |  |  |  |  |
| 1531015 |  | Proc Small Network Switch (DAQ) PR | 41d | 2012-01-03 | 2012-03-01 | 9-120M FS+58d | 188d | 0d | COMP SCIENT [40 h] | 2,624.8 | CHUDAKOV | 1 | 1 | D |  | EUGENE C | 11-026 |  | 11-006 | 12-021F |  |  | APP |  | 531 |  | 12-054F |  |  |  |  |
| 1531075 |  | Proc Consoles (DAQ) PR | 41d | 2012-01-03 | 2012-03-01 | 9-120M FS+58d | 227d | 203d | SCIENTIST [40 h] | 2,824.4 | CHUDAKOV | 1 | 1 | D | 07-024 | EUGENE C | 11-026 |  | 11-006 | 12-021F | 07-027 |  | APP |  | 531 |  | 12-054F |  |  |  |  |
| 1531085 |  | Proc funiture (DAQ) PR | 41d | 2012-01-03 | 2012-03-01 | 9-120M FS+58d | 235d | 191d | SCIENTIST [80 h] | 5,648.8 | CHUDAKOV | 1 | 1 | D |  | EUGENE C | 11-026 |  | 11-006 | 12-021F |  |  | APP |  | 531 |  | 12-054F |  |  |  |  |
| 1531190 |  | Test embedded computers for controls | 118d | 2012-01-31 | 2012-07-17 | 1531215, 1531205, 1531185 | 141d | 92d | SCIENTIST [40 h] | 2,824.4 | CHUDAKOV | 1 | 1 | D |  | EUGENE C | 11-026 | 10-042 | 11-006 | 12-021F |  |  |  |  |  |  |  |  |  |  |  |
| 1531220 |  | Proc PLC Point I/O Modules PR | 42d | 2012-01-31 | 2012-03-29 | 1531215 | 105d | 84d | SCIENTIST [40 h] | 2,824.4 | CHUDAKOV | 1 | 1 | D |  | EUGENE C | 11-026 | 10-042 | 11-006 | 12-021 |  |  |  |  |  |  |  |  |  |  |  |
| 1531005c |  | Proc Single Board Computing Second items (DAQ) Part A | 84d | 2012-02-29 | 2012-06-27 | 1531005ba | 314d |  | PROCUREMENT<$50K 60 | 11,000 | CHUDAKOV | 1 | 1 | D |  | EUGENE C | 11-026 |  | 11-006 | 12-021 |  |  | APP |  | 531 |  | 12-054F |  | 12-055 |  |  |
| 1531005ca |  | Proc Single Board Computing Second items (DAQ) Part B | 84d | 2012-02-29 | 2012-06-27 | 1531005ba | 314d |  | PROCUREMENT<$50K 60 | 29,000 | CHUDAKOV | 1 | 1 | D |  | EUGENE C | 11-026 |  | 11-006 | 12-021 |  |  | APP |  | 531 |  | 12-054F |  | 12-055 |  |  |
| 1531032 |  | Proc Online Computers (DAQ) Phase 1 Part A | 172d | 2012-03-01 | 2012-10-31 | 1531030 FS-65d | 161d | 77d | PROCUREMENT<$50K 60 NO ESCALATION FY13 | 12,000 | CHUDAKOV | 1 | 1 | D | 07-024 | EUGENE C | 11-026 |  | 11-006 | 12-021 | 07-027 |  | APP |  | 531 | 09-012 | 12-054F |  | 12-055 |  |  |
| 1531032a |  | Proc Online Computers (DAQ) Phase 1 Part B | 172d | 2012-03-01 | 2012-10-31 | 1531030 FS-65d | 161d | 77d | PROCUREMENT<$50K 60 NO ESCALATION FY13 | 23,000 | CHUDAKOV | 1 | 1 | D | 07-024 | EUGENE C | 11-026 |  | 11-006 | 12-021 | 07-027 |  | APP |  | 531 | 09-012 | 12-054F |  | 12-055 |  |  |
| 1531017 |  | Proc Small Network Switch (DAQ) Phase 1 | 84d | 2012-03-02 | 2012-06-29 | 1531015 | 188d | 0d | PROCUREMENT<$50K 60 | 25,797.5 | CHUDAKOV | 1 | 1 | D |  | EUGENE C | 11-026 |  | 11-006 | 12-021F |  |  | APP |  | 531 |  | 12-054F |  |  |  |  |
| 1531030 |  | Proc Online Computers (DAQ) PR | 43d | 2012-04-02 | 2012-05-31 | 9-120M FS+120d | 161d | 0d | SCIENTIST [40 h]; COMP SCIENT [40 h] | 5,449.2 | CHUDAKOV | 1 | 1 | D | 07-024 | EUGENE C | 11-026 |  | 11-006 | 12-021F | 07-027 |  | APP |  | 531 | 09-012 | 12-054F |  |  |  |  |
| 1531060 |  | Proc Wireless (DAQ) PR | 33d | 2012-04-02 | 2012-05-16 | 9-120M FS+120d | 219d | 0d | COMP SCIENT [40 h] | 2,624.8 | CHUDAKOV | 1 | 1 | D |  | EUGENE C | 11-026 |  | 11-006 | 12-021F |  |  | APP |  | 531 |  | 12-054F |  |  |  |  |
| 1531050 |  | Proc terminal servers (DAQ) PR | 43d | 2012-05-01 | 2012-07-02 | 9-120M FS+141d | 186d | 0d | COMP SCIENT [40 h] | 2,624.8 | CHUDAKOV | 1 | 1 | D |  | EUGENE C | 11-026 |  | 11-006 | 12-021F |  |  | APP |  | 531 |  | 12-054F |  |  |  |  |
| 1531055 |  | Proc UPS (DAQ) PR | 42d | 2012-05-01 | 2012-06-29 | 9-120M FS+141d | 187d | 0d | SCIENTIST [80 h]; COMP SCIENT [40 h] | 8,273.6 | CHUDAKOV | 1 | 1 | D |  | EUGENE C | 11-026 |  | 11-006 | 12-021F |  |  | APP |  | 531 |  | 12-054F |  |  |  |  |
| 1531092 |  | Proc Test Setup Equipmnt (DAQ) Part A | 129d | 2012-05-01 | 2012-10-31 | 9-120M FS+141d, 1531090 | 166d | 92d | PROCUREMENT<$50K 60 NO ESCALATION FY13 | 40,500 | CHUDAKOV | 1 | 1 | D |  | EUGENE C | 11-026 |  | 11-006 | 12-021 |  |  | APP |  | 531 |  |  |  | 12-055 |  |  |
| 1531092a |  | Proc Test Setup Equipmnt (DAQ) Part B | 129d | 2012-05-01 | 2012-10-31 | 9-120M FS+141d, 1531090 | 166d | 92d | PROCUREMENT<$50K 60 NO ESCALATION FY13 | 4,500 | CHUDAKOV | 1 | 1 | D |  | EUGENE C | 11-026 |  | 11-006 | 12-021 |  |  | APP |  | 531 |  |  |  | 12-055 |  |  |
| 1531062 |  | Proc Wireless (DAQ) | 83d | 2012-05-17 | 2012-09-13 | 1531060 | 219d | 195d | PROCUREMENT<$50K 60 | 46,435.5 | CHUDAKOV | 1 | 1 | D |  | EUGENE C | 11-026 |  | 11-006 | 12-021F |  |  | APP |  | 531 |  | 12-054F |  |  |  |  |
| 1531010 |  | Proc Large Network Switch (DAQ) PR | 42d | 2012-06-01 | 2012-07-31 | 9-120M FS+163d | 167d | 0d | COMP SCIENT [40 h] | 2,624.8 | CHUDAKOV | 1 | 1 | D |  | EUGENE C | 11-026 |  | 11-006 | 12-021F |  |  | APP |  | 531 |  | 12-054F |  |  |  |  |
| 1531160 |  | Proc VME based electronic for Controls/Monitoring | 65d | 2012-06-01 | 2012-08-31 | 9-120M FS+163d, 1531155 | 20d | 0d | PROCUREMENT<$50K 60 | 45,000 | CHUDAKOV | 1 | 1 | D |  | EUGENE C | 11-026 | 10-042 | 11-006 | 12-021 |  |  |  |  |  |  |  |  |  |  |  |
| 1531145 |  | Proc Net Switches for Controls PR FY12 | 67d | 2012-06-27 | 2012-09-28 | 9-120M FS+180d | 65d | 0d | SCIENTIST [26.8 h] | 1,892.35 | CHUDAKOV | 1 | 1 | D |  | EUGENE C | 11-026 | 10-042 | 11-006 |  |  |  |  |  |  |  |  |  |  | 12-053 |  |
| 1531018 |  | Proc Small Network Switch (DAQ) Phase 2 | 84d | 2012-07-02 | 2012-10-26 | 1531017 | 188d | 164d | PROCUREMENT<$50K 60 NO ESCALATION FY13 | 25,797.5 | CHUDAKOV | 1 | 1 | D |  | EUGENE C | 11-026 |  | 11-006 | 12-021F |  |  | APP |  | 531 |  | 12-054F |  |  |  |  |
| 1531057 |  | Proc UPS (DAQ) | 85d | 2012-07-02 | 2012-10-29 | 1531055 | 187d | 163d | PROCUREMENT>$50K 69 NO ESCALATION FY13; PROCUREMENT<$50K 60 NO ESCALATION FY13 | 78,424.4 | CHUDAKOV | 1 | 1 | D |  | EUGENE C | 11-026 |  | 11-006 | 12-021F |  |  | APP |  | 531 |  | 12-054F |  |  |  |  |
| 1531052 |  | Proc terminal servers (DAQ) | 85d | 2012-07-03 | 2012-10-30 | 1531050 | 186d | 162d | PROCUREMENT<$50K 60 NO ESCALATION FY13 | 8,255.2 | CHUDAKOV | 1 | 1 | D |  | EUGENE C | 11-026 |  | 11-006 | 12-021F |  |  | APP |  | 531 |  | 12-054F |  |  |  |  |
| 1531045 |  | Proc Telecom Installation (DAQ) PR | 43d | 2012-07-04 | 2012-08-31 | 9-120M FS+185d | 69d | 0d | SCIENTIST [40 h] | 2,824.4 | CHUDAKOV | 1 | 1 | D |  | EUGENE C | 11-026 |  | 11-006 | 12-021 |  |  | APP |  | 531 |  | 12-054F |  |  |  |  |
| 1531225 |  | Proc PLC Point I/O Modules Phase 1 | 67d | 2012-07-30 | 2012-10-31 | 1531220, 9-120M FS+203d, 1531215 FS+20d | 21d | 0d | PROCUREMENT<$50K 60 NO ESCALATION FY13 | 20,000 | CHUDAKOV | 1 | 1 | D |  | EUGENE C | 11-026 | 10-042 | 11-006 | 12-021 |  |  |  |  |  |  |  |  |  |  |  |
| 1531012 |  | Proc Large Network Switch (DAQ) | 83d | 2012-08-01 | 2012-11-28 | 1531010 | 167d | 143d | PROCUREMENT<$50K 60 NO ESCALATION FY13; PROCUREMENT>$50K 69 NO ESCALATION FY13 | 67,073.5 | CHUDAKOV | 1 | 1 | D |  | EUGENE C | 11-026 |  | 11-006 | 12-021F |  |  | APP |  | 531 |  | 12-054F |  |  |  |  |
| 1531135 |  | Proc infiniband Switch PR | 42d | 2012-08-01 | 2012-09-28 | 9-120M FS+205d | 149d | 0d | COMP SCIENT [40 h] | 2,624.8 | CHUDAKOV | 1 | 1 | D |  | EUGENE C | 11-026 | 10-042 | 11-006 | 12-021 |  |  |  |  |  |  | 12-054F |  |  |  |  |
| 1531048 |  | Proc Fibers Installation from Rack Room to Telecom Room (DAQ) | 127d | 2012-10-01 | 2013-04-09 | 9-130M | 81d | 57d | PROCUREMENT<$50K 60 | 10,319 | CHUDAKOV | 1 | 1 | D |  | EUGENE C | 11-026 |  | 11-006 | 12-021 |  |  | APP |  | 531 |  | 12-054 |  |  |  |  |
| 15311013E |  | FY13 Travel (DAQ) | 59d | 2012-10-01 | 2012-12-31 | 15311012E | 189d |  | TRAVEL | 1,597.23 | CHUDAKOV | 1 | 1 | D | 07-024 | EUGENE C | 11-026 |  | 11-006 |  |  |  |  |  |  |  |  |  |  |  | 08-052 |
| 1531145a |  | Proc Net Switches for Controls PR FY13 | 33d | 2012-10-01 | 2012-11-14 | 1531145 | 65d | 0d | SCIENTIST [13.2 h] | 961.75 | CHUDAKOV | 1 | 1 | D |  | EUGENE C | 11-026 | 10-042 | 11-006 |  |  |  |  |  |  |  |  |  |  | 12-053 |  |
| 1531165 |  | Install VME based electronic for Controls/Monitoring | 120d | 2012-10-02 | 2013-04-01 | 1531160 FS+20d | 20d | 0d | SCIENTIST [240 h] | 17,486.4 | CHUDAKOV | 1 | 1 | D |  | EUGENE C | 11-026 | 10-042 | 11-006 | 12-021 |  |  |  |  |  |  |  |  |  |  |  |
| 1531140 |  | Proc infiniband Switch | 78d | 2012-10-30 | 2013-02-28 | 1531135 FS+21d | 149d |  | PROCUREMENT<$50K 60 | 15,478.5 | CHUDAKOV | 1 | 1 | D |  | EUGENE C | 11-026 | 10-042 | 11-006 | 12-021 |  |  |  |  |  |  | 12-054F |  |  |  |  |
| 1531150 |  | Proc Net Switches for Controls | 63d | 2012-11-15 | 2013-02-25 | 1531145a | 65d | 45d | PROCUREMENT<$50K 60 | 12,777.81 | CHUDAKOV | 1 | 1 | D |  | EUGENE C | 11-026 | 10-042 | 11-006 |  |  |  |  |  |  |  |  |  |  |  |  |
| 1531040 |  | Proc file servers (DAQ) PR | 42d | 2012-11-28 | 2013-02-04 | 9-130M FS+40d | 24d | 0d | COMP SCIENT [40 h]; SCIENTIST [40 h] | 5,622.8 | CHUDAKOV | 1 | 1 | D | 07-024 | EUGENE C | 11-026 |  | 11-006 | 12-021 | 07-027 |  | APP |  | 531 |  | 12-054F |  |  |  |  |
| 1531070 |  | Proc Fiber Cables for Counting House to Hall (DAQ) | 122d | 2012-11-28 | 2013-05-29 | 9-130M FS+40d, 1531065 | 46d | 22d | PROCUREMENT<$50K 60 | 25,797.5 | CHUDAKOV | 1 | 1 | D |  | EUGENE C | 11-026 |  | 11-006 | 12-021 |  |  | APP |  | 531 |  | 12-054 |  |  |  |  |
| 1531227 |  | Proc PLC Point I/O Modules Phase 2 Part A | 79d | 2012-11-29 | 2013-03-29 | 1531225 FS+18d | 21d | 1d | PROCUREMENT<$50K 60 | 17,232.73 | CHUDAKOV | 1 | 1 | D |  | EUGENE C | 11-026 | 10-042 | 11-006 | 12-021 |  |  |  |  |  |  |  |  | 12-055 |  |  |
| 1531227a |  | Proc PLC Point I/O Modules Phase 2 Part B | 79d | 2012-11-29 | 2013-03-29 | 1531225 FS+18d | 21d | 1d | PROCUREMENT<$50K 60 | 16,819.97 | CHUDAKOV | 1 | 1 | D |  | EUGENE C | 11-026 | 10-042 | 11-006 | 12-021 |  |  |  |  |  |  |  |  | 12-055 |  |  |
| 1531087 |  | Proc furniture (DAQ) | 121d | 2012-12-03 | 2013-05-31 | 1531085, 9-130M FS+43d | 44d | 20d | PROCUREMENT>$50K 69; PROCUREMENT<$50K 60 | 51,595 | CHUDAKOV | 1 | 1 | D |  | EUGENE C | 11-026 |  | 11-006 | 12-021 |  |  | APP |  | 531 |  | 12-054F |  |  |  |  |
| 1531077 |  | Proc Consoles (DAQ) | 129d | 2012-12-19 | 2013-06-28 | 1531075, 9-130M FS+55d | 24d | 0d | PROCUREMENT<$50K 60 | 41,276 | CHUDAKOV | 1 | 1 | D | 07-024 | EUGENE C | 11-026 |  | 11-006 | 12-021 | 07-027 |  | APP |  | 531 |  | 12-054F |  |  |  |  |
| 1531025 |  | Proc RAID disks (DAQ) PR | 40d | 2013-01-03 | 2013-03-01 | 9-130M FS+60d | 64d | 0d | SCIENTIST [40 h]; COMP SCIENT [40 h] | 5,622.8 | CHUDAKOV | 1 | 1 | D | 07-024 | EUGENE C | 11-026 |  | 11-006 | 12-021 | 07-027 |  | APP |  | 531 | 09-012 |  |  |  |  |  |
| 1531095 |  | Install Crates (DAQ) | 55d | 2013-01-03 | 2013-03-22 | 9-130M FS+60d, 1531093, 1562195 FS-20d, 1544005d | 20d | 0d | COMP SCIENT [80 h]; ELEC TECH [360 h]; SCIENTIST [80 h] | 27,640 | CHUDAKOV | 1 | 1 | D |  | EUGENE C | 11-026 | 10-042 | 11-006 | 12-021 |  |  |  |  |  |  | 12-054 |  |  |  |  |
| 1531195 |  | Proc remaining embedded computers for controls | 32d | 2013-01-03 | 2013-02-19 | 9-130M FS+60d, 1531190 FS+20d | 49d | 29d | PROCUREMENT<$50K 60 | 5,159.5 | CHUDAKOV | 1 | 1 | D |  | EUGENE C | 11-026 | 10-042 | 11-006 | 12-021 |  |  |  |  |  |  | 12-054 |  |  |  |  |
| 1531047 |  | Proc Telecom Installation (DAQ) | 78d | 2013-01-04 | 2013-04-25 | 1531045 FS+80d | 69d | 45d | PROCUREMENT<$50K 60 | 15,478.5 | CHUDAKOV | 1 | 1 | D |  | EUGENE C | 11-026 |  | 11-006 | 12-021 |  |  | APP |  | 531 |  | 12-054 |  |  |  |  |

Notes:
- 1531220: Explanation: $67.25 "S" History change per CR12-021

| ID | Activity | Duration | Start | Finish | Predecessors | Total float | Free float | Calendar | Resources | Cost | RESP - Responsibility | STRT%COMP for CM EVM | FNSH%COMP for CM EVM | HALL D Related Milestones | Advance Purchase Plan > 500K | CAM RESPONSIBLE | 12 GEV MAJOR PROCUREMENT CATAGORY | CR 11-006 | CR 11-026 | CR 12-021 | CR 12-054 | CR 07-024 | CR 07-027 | CR 09-012 | CR 10-042 | CR 13-014 | ReBaseline Actuals Adjustment | Original Activity ID Rebaseline | Over Under Fixed | EVMS Reporting Codes | CR 13-007 | BOE Procurement | CR 13-015 | Post Rebaseline | Obligated Prior to Rebaseline | BOE Labor | CR 12-040 | CR 12-055 | CR 14-001 |
| --- | --- | --- | --- | --- | --- | --- | --- | --- | --- | --- | --- | --- | --- | --- | --- | --- | --- | --- | --- | --- | --- | --- | --- | --- | --- | --- | --- | --- | --- | --- | --- | --- | --- | --- | --- | --- | --- | --- | --- |
| 1531022 | Proc EB nodes (DAQ) Phase 1 | 60d | 2013-02-01 | 2013-04-26 | 9-130M FS+80d, 1531020 | 68d | 44d |  | PROCUREMENT<$50K 60 | 27,861.3 | CHUDAKOV | 1 | 1 | D | APP | EUGENE C | 531 | 11-006 | 11-026 | 12-021 | 12-054F |  |  |  |  |  |  |  |  |  |  |  |  |  |  |  |  |  |  |
| 1531042 | Proc file servers (DAQ) | 102d | 2013-02-05 | 2013-06-28 | 1531040 | 24d | 0d |  | PROCUREMENT<$50K 60 | 36,116.5 | CHUDAKOV | 1 | 1 | D | APP | EUGENE C | 531 | 11-006 | 11-026 | 12-021 | 12-054F | 07-024 | 07-027 |  |  |  |  |  |  |  |  |  |  |  |  |  |  |  |  |
| 1531027 | Proc RAID disks (DAQ) | 84d | 2013-03-04 | 2013-06-28 | 1531025 | 64d |  |  | PROCUREMENT>$50K 69; PROCUREMENT<$50K 60 | 56,754.5 | CHUDAKOV | 1 | 1 | D | APP | EUGENE C | 531 | 11-006 | 11-026 | 12-021 |  | 07-024 | 07-027 | 09-012 |  |  |  |  |  |  |  |  |  |  |  |  |  |  |  |
| 1531033 | Proc Online Computers (DAQ) Phase 2 | 64d | 2013-03-04 | 2013-05-31 | 9-130M FS+100d, 1531032a, 1531032 | 84d |  |  | PROCUREMENT<$50K 60 | 59,850.2 | CHUDAKOV | 1 | 1 | D | APP | EUGENE C | 531 | 11-006 | 11-026 | 12-021 |  | 07-024 | 07-027 | 09-012 |  |  |  |  |  |  |  |  |  |  |  |  |  |  |  |
| 1531105 | Install Trigger Electrnc's (DAQ) Phase 1 | 59d | 2013-03-25 | 2013-06-14 | 1531092a, 1531092, 1532007a, 1532007, 1531095, 1532005 | 74d |  |  | SCIENTIST [120 h]; ELEC TECH [120 h] | 14,208 | CHUDAKOV | 1 | 1 | D |  | EUGENE C |  | 11-006 | 11-026 | 12-021 | 12-054 |  |  |  |  |  |  |  |  |  |  |  |  |  |  |  |  |  |  |
| 1531110 | Install DAQ Electrnc's (DAQ) | 41d | 2013-03-25 | 2013-05-20 | 1531095 | 20d | 0d |  | ELEC TECH [400 h]; SCIENTIST [400 h] | 47,360 | CHUDAKOV | 1 | 1 | D |  | EUGENE C |  | 11-006 | 11-026 | 12-021 | 12-054 |  |  |  | 10-042 |  |  |  |  |  |  |  |  |  |  |  |  |  |  |
| 1531100 | Install Cabling (DAQ) | 64d | 2013-06-03 | 2013-08-30 | 1531095, 1531110 FS+8d | 20d |  |  | SCIENTIST [200 h]; COMP SCIENT [200 h]; ELEC TECH [160 h] | 35,400.4 | CHUDAKOV | 1 | 1 | D |  | EUGENE C |  | 11-006 | 11-026 | 12-021 | 12-054 |  |  |  | 10-042 |  |  |  |  |  |  |  |  |  |  |  |  |  |  |
| 1531035 | Proc large displays (DAQ) PR | 44d | 2013-07-01 | 2013-08-30 | 9-130M FS+184d | 20d |  |  | COMP SCIENT [40 h] | 2,708.4 | CHUDAKOV | 1 | 1 | D | APP | EUGENE C | 531 | 11-006 | 11-026 | 12-021 |  |  |  |  |  |  |  |  |  |  |  |  |  |  |  |  |  |  |  |
| 1531037 | Proc large displays (DAQ) (Future Activity Complete prior to Rebaseline) | 1d | 2013-08-30 | 2013-08-30 | 9-130M FS+227d | 20d |  |  | PROCUREMENT<$50K 60 |  | CHUDAKOV | 1 | 1 | D | APP | EUGENE C | 531 | 11-006 | 11-026 | 12-021 |  |  |  |  |  | 13-014 |  |  |  |  |  |  |  |  |  |  |  |  |  |
| 1531245 | Re-Baseline Actuals Adjustment | 1d | 2013-08-30 | 2013-08-30 | 9-130M FS+227d | 20d |  |  | PROCUREMENT>$50K 69 NO ESCALATION | -372,924.07 | CHUDAKOV | 1 | 1 |  |  | EUGENE C |  |  |  |  |  |  |  |  |  | 13-014 | ADJ |  |  |  |  |  |  |  |  |  |  |  |  |
| 2531005f | Proc Single Board Computing Remaining items (DAQ) | 84d | 2013-09-03 | 2014-01-10 | 9-130M FS+228d | 122d | 27d | 8/5 M-F w/JLAB Holidays ReBaseline | PROCUREMENT<$50K 60 NO ESCALATION FY14; PROCUREMENT>$50K 69 NO ESCALATION FY14 | 60,911 | CHUDAKOV | 1 | 1 | D | APP | EUGENE C | 531 | 11-006 | 11-026 | 12-021 | 12-054F |  |  |  |  |  |  | 2531005f | y | D | 13-007 | EV | 13-015 | PR | OB |  |  |  |  |
| 2531022 | Proc EB nodes (DAQ) | 62d | 2013-09-03 | 2013-11-27 | 9-130M FS+228d | 165d | 15d | 8/5 M-F w/JLAB Holidays ReBaseline | PROCUREMENT>$50K 69 NO ESCALATION; PROCUREMENT<$50K 60 NO ESCALATION FY14 | 45,500 | CHUDAKOV | 1 | 1 | D | APP | EUGENE C | 531 | 11-006 | 11-026 | 12-021 | 12-054F |  |  |  |  |  |  | 2531022 | y | D | 13-007 | VQ | 13-015 | PR | OB |  |  |  |  |
| 2531027 | Proc RAID disks (DAQ) | 62d | 2013-09-03 | 2013-11-27 | 9-130M FS+228d | 165d | 15d | 8/5 M-F w/JLAB Holidays ReBaseline | PROCUREMENT>$50K 69 NO ESCALATION | 25,500 | CHUDAKOV | 1 | 1 | D | APP | EUGENE C | 531 | 11-006 | 11-026 | 12-021 |  | 07-024 | 07-027 | 09-012 |  |  |  | 2531027 | y | D |  | VQ | 13-015 | PR | OB |  |  |  |  |
| 2531047 | Proc Telecom Installation (DAQ) | 43d | 2013-09-03 | 2013-10-31 | 9-130M FS+228d | 31d | 14d | 8/5 M-F w/JLAB Holidays ReBaseline | PROCUREMENT<$50K 60 NO ESCALATION FY14 | 3,150 | CHUDAKOV | 1 | 1 | D | APP | EUGENE C | 531 | 11-006 | 11-026 | 12-021 | 12-054 |  |  |  |  |  |  | 2531047 |  | D | 13-007 | PE | 13-015 | PR |  |  |  |  |  |
| 2531065 | Proc Fibers for Counting House to Hall (DAQ) PR FY13 | 20d | 2013-09-03 | 2013-09-30 | 9-130M FS+228d | 17d | 0d | 8/5 M-F w/JLAB Holidays ReBaseline | SR STAFF [27.59 h] | 3,216.99 | CHUDAKOV | 1 | 1 | D | APP | EUGENE C | 531 | 11-006 | 11-026 | 12-021F | 12-054F |  |  |  |  |  |  | 2531065 |  | H | 13-007F |  | 13-015 | PR |  | PE |  |  |  |
| 2531077 | Proc Consoles (DAQ) | 20d | 2013-09-03 | 2013-09-30 | 9-130M FS+228d | 54d | 10d | 8/5 M-F w/JLAB Holidays ReBaseline | PROCUREMENT<$50K 60 | 400 | CHUDAKOV | 1 | 1 | D | APP | EUGENE C | 531 | 11-006 | 11-026 | 12-021 | 12-054F | 07-024 | 07-027 |  |  |  |  | 2531077 | y | D | 13-007 | VQ | 13-015 | PR | OB |  |  |  |  |
| 2531105 | Install Trigger Electrnc's (DAQ) FY13 | 20d | 2013-09-03 | 2013-09-30 | 9-130M FS+228d | 19d | 0d | 8/5 M-F w/JLAB Holidays ReBaseline | ELEC ENG [9.64 h]; SCIENTIST [28.92 h]; ELEC TECH [38.55 h] | 4,564.43 | CHUDAKOV | 1 | 1 | D |  | EUGENE C |  | 11-006 | 11-026 | 12-021 | 12-054 |  |  |  |  |  |  | 2531105 |  | S | 13-007 |  | 13-015 | PR |  | PE |  |  |  |
| 2531115 | Install VME CPUs FY13 | 20d | 2013-09-03 | 2013-09-30 | 9-130M FS+228d | 17d | 0d | 8/5 M-F w/JLAB Holidays ReBaseline | SCIENTIST [58.18 h] | 4,238.99 | CHUDAKOV | 1 | 1 | D |  | EUGENE C |  | 11-006 | 11-026 | 12-021 | 12-054 |  |  |  | 10-042 |  |  | 2531115 |  | S | 13-007 |  | 13-015 | PR |  | PE | 12-040 |  |  |
| 2531140 | Proc infiniband Hardware | 31d | 2013-09-03 | 2013-10-15 | 9-130M FS+228d | 164d | 0d | 8/5 M-F w/JLAB Holidays ReBaseline | PROCUREMENT>$50K 69 NO ESCALATION | 13,710 | CHUDAKOV | 1 | 1 | D |  | EUGENE C |  | 11-006 | 11-026 | 12-021 | 12-054F |  |  |  | 10-042 |  |  | 2531140 | y | D | 13-007 | CP | 13-015 | PR | OB |  |  |  |  |
| 2531165 | Install VME based electronic for Controls/Monitoring FY13 | 20d | 2013-09-03 | 2013-09-30 | 9-130M FS+228d | 43d | 0d | 8/5 M-F w/JLAB Holidays ReBaseline | SCIENTIST [32.99 h] | 2,403.65 | CHUDAKOV | 1 | 1 | D |  | EUGENE C |  | 11-006 | 11-026 | 12-021 |  |  |  |  | 10-042 |  |  | 2531165 |  | S |  |  | 13-015 | PR |  | PE |  |  |  |
| 2531227aa | Proc IO Modules (DAQ) Batch 2 (Previously Obligated) | 42d | 2013-09-03 | 2013-10-30 | 9-130M FS+228d | 225d |  | 8/5 M-F w/JLAB Holidays ReBaseline | PROCUREMENT<$50K 60 NO ESCALATION FY14 | 4,978.67 | CHUDAKOV | 1 | 1 | D |  | EUGENE C |  | 11-006 | 11-026 | 12-021 |  |  |  |  | 10-042 |  |  | 2531227aa | y | D | 13-007 | EV | 13-015 | PR | OB |  |  | 12-055 |  |
| 2531227aa5 | Proc IO Modules (DAQ) Batch 2 | 42d | 2013-09-03 | 2013-10-30 | 9-130M FS+228d | 225d |  | 8/5 M-F w/JLAB Holidays ReBaseline | PROCUREMENT<$50K 60 NO ESCALATION FY14 | 6,116.3 | CHUDAKOV | 1 | 1 | D |  | EUGENE C |  | 11-006 | 11-026 | 12-021 |  |  |  |  | 10-042 |  |  | 2531227aa |  | D | 13-007 | EV | 13-015 | PR |  |  |  | 12-055 |  |
| 2531315 | Install Computing Infrastructure (DAQ) FY13 | 20d | 2013-09-03 | 2013-09-30 | 9-130M FS+228d | 500d | 0d | 8/5 M-F w/JLAB Holidays ReBaseline | SR STAFF [43.84 h] | 5,111.74 | CHUDAKOV | 1 | 1 | D |  | EUGENE C |  | 11-006 | 11-026 | 12-021 |  |  |  |  | 10-042 |  |  | 2531315 |  | S |  |  | 13-015 | PR |  | PE |  |  |  |
| 2531335 | Proc Accessories for Computing Cluster (DAQ) PR FY13 | 20d | 2013-09-03 | 2013-09-30 | 9-130M FS+228d | 95d | 0d | 8/5 M-F w/JLAB Holidays ReBaseline | SCIENTIST [25.81 h] | 1,880.52 | CHUDAKOV | 1 | 1 | D |  | EUGENE C |  | 11-006 | 11-026 | 12-021 |  |  |  |  | 10-042 |  |  | 2531335 |  | H |  |  | 13-015 | PR |  | PE |  |  |  |
| 2531350 | Proc Hardware for Microscope Voltage Control (DAQ) | 77d | 2013-09-03 | 2013-12-20 | 9-130M FS+228d | 128d | 0d | 8/5 M-F w/JLAB Holidays ReBaseline | PROCUREMENT<$50K 60 NO ESCALATION FY14 | 3,000 | CHUDAKOV | 1 | 1 | D |  | EUGENE C |  | 11-006 | 11-026 | 12-021 |  |  |  |  | 10-042 |  |  | 2531350 |  | D |  | EJ | 13-015 | PR |  |  |  |  |  |
| 2531390 | Installation Coordination | 20d | 2013-09-03 | 2013-09-30 | 9-130M FS+228d | 216d | 10d | 8/5 M-F w/JLAB Holidays ReBaseline | SCIENTIST [25 h] | 1,821.5 | CHUDAKOV | 1 | 1 | D |  | EUGENE C |  | 11-006 | 11-026 | 12-021 |  |  |  |  | 10-042 |  |  | 2531390 |  | E |  |  | 13-015 | PR |  | PE |  |  |  |
| 2531065a | Proc Fibers for Counting House to Hall (DAQ) PR FY14 | 9d | 2013-10-01 | 2013-10-11 | 9-130M FS+228d, 2531065 | 17d | 0d | 8/5 M-F w/JLAB Holidays ReBaseline | SR STAFF [12.41 h] | 1,493.17 | CHUDAKOV | 1 | 1 | D | APP | EUGENE C | 531 | 11-006 | 11-026 | 12-021F | 12-054F |  |  |  |  |  |  | 2531065 |  | H | 13-007F |  | 13-015 | PR |  | PE |  |  | 14-001 |
| 2531105a | Install Trigger Electrnc's (DAQ) FY14 | 146d | 2013-10-01 | 2014-05-07 | 9-130M FS+228d, 2531105 | 19d | 0d | 8/5 M-F w/JLAB Holidays ReBaseline | ELEC ENG [70.36 h]; SCIENTIST [211.08 h]; ELEC TECH [281.44 h] | 34,380.01 | CHUDAKOV | 1 | 1 | D |  | EUGENE C |  | 11-006 | 11-026 | 12-021 | 12-054 |  |  |  |  |  |  | 2531105 |  | S | 13-007 |  | 13-015 | PR |  | PE |  |  | 14-001 |
| 2531115a | Install VME CPUs FY14 | 90d | 2013-10-01 | 2014-02-18 | 9-130M FS+228d, 2531115 | 17d |  | 8/5 M-F w/JLAB Holidays ReBaseline | SCIENTIST [261.82 h] | 19,683.63 | CHUDAKOV | 1 | 1 | D |  | EUGENE C |  | 11-006 | 11-026 | 12-021 | 12-054 |  |  |  | 10-042 |  |  | 2531115 |  | S | 13-007 |  | 13-015 | PR |  | PE | 12-040 |  | 14-001 |
| 2531165a | Install VME based electronic for Controls/Monitoring FY14 | 77d | 2013-10-01 | 2014-01-30 | 2531165, 9-130M FS+228d | 43d | 32d | 8/5 M-F w/JLAB Holidays ReBaseline | SCIENTIST [127.01 h] | 9,548.61 | CHUDAKOV | 1 | 1 | D |  | EUGENE C |  | 11-006 | 11-026 | 12-021 |  |  |  |  | 10-042 |  |  | 2531165 |  | S |  |  | 13-015 | PR |  | PE |  |  | 14-001 |
| 2531178 | Software Licenses and Fees | 246d | 2013-10-01 | 2014-09-29 | 9-140M | 101d |  | 8/5 M-F w/JLAB Holidays ReBaseline | PROCUREMENT<$50K 60 | 1,857.42 | CHUDAKOV | 1 | 1 | D |  | EUGENE C |  | 11-006 | 11-026 | 12-021 |  |  |  |  | 10-042 |  |  | 2531178 |  | D |  | PE | 13-015 | PR |  |  |  |  | 14-001 |
| 2531315a | Install Computing Infrastructure (DAQ) FY14 | 53d | 2013-10-01 | 2013-12-16 | 9-130M FS+228d, 2531315 | 500d | 0d | 8/5 M-F w/JLAB Holidays ReBaseline | SR STAFF [116.16 h] | 13,976.37 | CHUDAKOV | 1 | 1 | D |  | EUGENE C |  | 11-006 | 11-026 | 12-021 |  |  |  |  | 10-042 |  |  | 2531315 |  | S |  |  | 13-015 | PR |  | PE |  |  | 14-001 |
| 2531335a | Proc Accessories for Computing Cluster (DAQ) PR FY14 | 11d | 2013-10-01 | 2013-10-15 | 2531335, 9-130M FS+228d | 95d | 0d | 8/5 M-F w/JLAB Holidays ReBaseline | SCIENTIST [14.19 h] | 1,066.8 | CHUDAKOV | 1 | 1 | D |  | EUGENE C |  | 11-006 | 11-026 | 12-021 |  |  |  |  | 10-042 |  |  | 2531335 |  | H |  |  | 13-015 | PR |  | PE |  |  | 14-001 |
| 2531070 | Proc Fibers for Counting House to Hall (DAQ) | 29d | 2013-10-14 | 2013-11-21 | 2531065, 2531065a | 17d | 0d | 8/5 M-F w/JLAB Holidays ReBaseline | PROCUREMENT<$50K 60 | 35,743.98 | CHUDAKOV | 1 | 1 | D | APP | EUGENE C | 531 | 11-006 | 11-026 | 12-021 | 12-054 |  |  |  |  |  |  | 2531070 |  | D | 13-007 | EV | 13-015 | PR |  |  |  |  | 14-001 |
| 2531375 | Check-out Counting House (DAQ) | 31d | 2013-10-15 | 2013-11-26 | 2531390, 9-140M FS+10d, 2531077 | 206d |  | 8/5 M-F w/JLAB Holidays ReBaseline | SCIENTIST [80 h] | 6,014.4 | CHUDAKOV | 1 | 1 | D |  | EUGENE C |  | 11-006 | 11-026 | 12-021 |  |  |  |  | 10-042 |  |  | 2531375 |  | H |  |  | 13-015 | PR |  | EJ |  |  | 14-001 |
| 2531097 | Install infiniband network (DAQ) | 42d | 2013-10-16 | 2013-12-16 | 2531140 | 164d | 57d | 8/5 M-F w/JLAB Holidays ReBaseline | SR STAFF [160 h] | 19,251.2 | CHUDAKOV | 1 | 1 | D |  | EUGENE C |  | 11-006 | 11-026 | 12-021 | 12-054 |  |  |  | 10-042 |  |  | 2531097 |  | S | 13-007 |  | 13-015 | PR |  | PE |  |  | 14-001 |
| 2531005fa | Proc Single Board Computing Remaining items (DAQ) Phase 2 | 55d | 2013-11-01 | 2014-01-31 | 9-140M FS+23d | 108d | 13d | 8/5 M-F w/JLAB Holidays ReBaseline | PROCUREMENT<$50K 60; PROCUREMENT>$50K 69 | 159,638.03 | CHUDAKOV | 1 | 1 | D | APP | EUGENE C | 531 | 11-006 | 11-026 | 12-021 | 12-054F |  |  |  |  |  |  | 2531005fa |  | D | 13-007 | EV | 13-015 | PR |  |  |  |  | 14-001 |
| 2531089 | Procure Conference Equipment (DAQ) | 75d | 2013-11-01 | 2014-02-28 | 9-140M FS+23d | 149d |  | 8/5 M-F w/JLAB Holidays ReBaseline | PROCUREMENT<$50K 60 | 11,178.78 | CHUDAKOV | 1 | 1 | D | APP | EUGENE C | 531 | 11-006 | 11-026 | 12-021 | 12-054F |  |  |  |  |  |  | 2531089 |  | D | 13-007 | PE | 13-015 | PR |  |  |  |  | 14-001 |
| 2531310 | Install DAQ Equipment in Hall (DAQ) | 84d | 2013-11-01 | 2014-03-13 | 2562405 FS-32d | 0d |  | 8/5 M-F w/JLAB Holidays ReBaseline | SCIENTIST [160 h] | 12,028.8 | CHUDAKOV | 1 | 1 | D |  | EUGENE C |  | 11-006 | 11-026 | 12-021 |  |  |  |  | 10-042 |  |  | 2531310 |  | S |  |  | 13-015 | PR |  | EJ |  |  | 14-001 |
| 2531330 | Proc L3 Farm Infrastucture (DAQ) | 30d | 2013-11-01 | 2013-12-16 | 9-140M FS+23d | 154d | 59d | 8/5 M-F w/JLAB Holidays ReBaseline | PROCUREMENT>$50K 69 NO ESCALATION | 34,101 | CHUDAKOV | 1 | 1 | D |  | EUGENE C |  | 11-006 | 11-026 | 12-021 |  |  |  |  | 10-042 |  |  | 2531330 | y | D |  | EV | 13-015 | PR | OB |  |  |  |  |
| 2531395 | Procure Small UPSs for Tagger Hall and Hall D (DAQ) | 77d | 2013-11-01 | 2014-03-04 | 9-140M FS+23d | 147d |  | 8/5 M-F w/JLAB Holidays ReBaseline | PROCUREMENT<$50K 60 | 21,648.23 | CHUDAKOV | 1 | 1 | D |  | EUGENE C |  | 11-006 | 11-026 | 12-021 |  |  |  |  | 10-042 |  |  | 2531395 |  | D |  | CP | 13-015 | PR |  |  |  |  | 14-001 |
| 2531340 | Proc Accessories for Computing Cluster (DAQ) | 82d | 2013-11-12 | 2014-03-20 | 2531335 FS+19d, 2531335a FS+19d | 95d | 0d | 8/5 M-F w/JLAB Holidays ReBaseline | PROCUREMENT<$50K 60 | 10,348.93 | CHUDAKOV | 1 | 1 | D |  | EUGENE C |  | 11-006 | 11-026 | 12-021 |  |  |  |  | 10-042 |  |  | 2531340 |  | D |  | CP | 13-015 | PR |  |  |  |  | 14-001 |
| 2531360 | Patch Panels and Cu Cables to CH (DAQ) | 84d | 2013-11-27 | 2014-04-08 | 2562645 FS+5d, 9-140M FS+41d, 2562645a FS+5d | 122d |  | 8/5 M-F w/JLAB Holidays ReBaseline | MECH TECH [40 h]; PROCUREMENT<$50K 60 | 5,504.45 | CHUDAKOV | 1 | 1 | D |  | EUGENE C |  | 11-006 | 11-026 | 12-021 |  |  |  |  | 10-042 |  |  | 2531360 |  | D |  | CP | 13-015 | PR |  | PE |  |  | 14-001 |
| 2531088 | Procure and Install cameras in the hall (DAQ) | 49d | 2013-12-02 | 2014-02-19 | 9-140M FS+42d | 156d |  | 8/5 M-F w/JLAB Holidays ReBaseline | ELEC ENG [40 h]; PROCUREMENT<$50K 60 | 23,643.2 | CHUDAKOV | 1 | 1 | D | APP | EUGENE C | 531 | 11-006 | 11-026 | 12-021 | 12-054F |  |  |  |  |  |  | 2531088 |  | D | 13-007 | CP | 13-015 | PR |  | PE |  |  | 14-001 |
| 2531100 | Install DAQ fibers to switches (DAQ) | 68d | 2013-12-02 | 2014-03-18 | 9-140M FS+42d | 107d | 0d | 8/5 M-F w/JLAB Holidays ReBaseline | PROCUREMENT<$50K 60 | 19,695.88 | CHUDAKOV | 1 | 1 | D |  | EUGENE C |  | 11-006 | 11-026 | 12-021 | 12-054 |  |  |  | 10-042 |  |  | 2531100 |  | D | 13-007 | EV | 13-015 | PR |  |  |  |  | 14-001 |
| 2531400 | Procure and Install Voltage Chassis Remote Reset | 59d | 2013-12-05 | 2014-03-10 | 9-140M FS+45d | 143d |  | 8/5 M-F w/JLAB Holidays ReBaseline | PROCUREMENT<$50K 60; ELEC TECH [40 h] | 4,325.2 | CHUDAKOV | 1 | 1 | D |  | EUGENE C |  | 11-006 | 11-026 | 12-021 |  |  |  |  | 10-042 |  |  | 2531400 |  | D |  | PE | 13-015 | PR |  | EJ |  |  | 14-001 |
| 2531365 | Sys Admin Support (DAQ) | 188d | 2014-01-06 | 2014-09-30 | 2531315 FS+6d, 2531315a FS+6d | 500d |  | 8/5 M-F w/JLAB Holidays ReBaseline | SR STAFF [160 h] | 19,251.2 | CHUDAKOV | 1 | 1 | D |  | EUGENE C |  | 11-006 | 11-026 | 12-021 |  |  |  |  | 10-042 |  |  | 2531365 |  | E |  |  | 13-015 | PR |  | PE |  |  | 14-001 |
| 2531380 | Check-out Cabling (DAQ) | 30d | 2014-03-19 | 2014-04-29 | 2531100, 2531097 | 107d |  | 8/5 M-F w/JLAB Holidays ReBaseline | SR STAFF [80 h] | 9,625.6 | CHUDAKOV | 1 | 1 | D |  | EUGENE C |  | 11-006 | 11-026 | 12-021 |  |  |  |  | 10-042 |  |  | 2531380 |  | H |  |  | 13-015 | PR |  | PE |  |  | 14-001 |
| 2531370 | Check-out Online Computers (DAQ) | 40d | 2014-03-21 | 2014-05-15 | 2531027, 2531005f FS+21d, 2531330, 2531340, 2531022, 2531005fa FS+21d | 95d |  | 8/5 M-F w/JLAB Holidays ReBaseline | SCIENTIST [40 h]; MECH TECH [120 h] | 8,685.6 | CHUDAKOV | 1 | 1 | D |  | EUGENE C |  | 11-006 | 11-026 | 12-021 |  |  |  |  | 10-042 |  |  | 2531370 |  | S |  |  | 13-015 | PR |  | PE |  |  | 14-001 |
| 2531385 | Check-out DAQ Hardware (DAQ) | 110d | 2014-04-25 | 2014-09-30 | 2531115a FS+30d, 2531115 FS+30d, 2531310 FS+30d | 0d |  | 8/5 M-F w/JLAB Holidays ReBaseline | SCIENTIST [120 h] | 9,021.6 | CHUDAKOV | 1 | 1 | D |  | EUGENE C |  | 11-006 | 11-026 | 12-021 |  |  |  |  | 10-042 |  |  | 2531385 |  | S |  |  | 13-015 | PR |  | EJ |  |  | 14-001 |
| 2531125 | Check-out Trigger Electrnc's (DAQ) | 63d | 2014-05-08 | 2014-08-06 | 2531105, 2531105a | 19d | 0d | 8/5 M-F w/JLAB Holidays ReBaseline | ELEC ENG [80 h]; SCIENTIST [360 h]; ELEC TECH | 33,075.2 | CHUDAKOV | 1 | 1 | D |  | EUGENE C |  | 11-006 | 11-026 | 12-021 | 12-054 |  |  |  |  |  |  | 2531125 |  | S | 13-007 |  | 13-015 | PR |  | EJ |  |  | 14-001 |
| 2531033 | Proc Servers for EPICS Archiving (DAQ) | 50d | 2014-10-01 | 2014-12-11 | 9-155M | 447d | 70d | 8/5 M-F w/JLAB Holidays ReBaseline | PROCUREMENT<$50K 60 | 21,669.9 | CHUDAKOV | 1 | 1 | D | APP | EUGENE C | 531 | 11-006 | 11-026 | 12-021 |  | 07-024 | 07-027 | 09-012 |  |  |  | 2531033 |  | D | 13-007 | VQ | 13-015 | PR |  |  |  |  | 14-001 |

Notes:
- 2531227aa: Explanation: Holding 18K from 227 12/20/12
- 2531227aa5: Explanation: Holding 18K from 227 12/20/12

| ID | WBS | Activity | Duration | Start | Finish | Predecessors | Total float | Free float | Resources | Cost | RESP - Responsibility | STRT%COMP for CM EVM | FNSH%COMP for CM EVM | HALL D Related Milestones | CAM RESPONSIBLE | CR 11-006 | CR 11-026 | CR 12-001 | CR 12-021 | CR 12-054 | CR 07-024 | CR 07-027 | 12 GEV MAJOR PROCUREMENT CATAGORY | CR 12-053 | Inter Project Link (IPL) |
| --- | --- | --- | --- | --- | --- | --- | --- | --- | --- | --- | --- | --- | --- | --- | --- | --- | --- | --- | --- | --- | --- | --- | --- | --- | --- |
|  | 2 | **1.5.3.2 ONLINE COMPUTING** |  | 2011-04-01 | 2014-09-30 |  |  |  |  |  |  |  |  |  |  |  |  |  |  |  |  |  |  |  |  |
| 1532060 |  | Plan Experiment Controls Framework FY11 (FY12 @ 1532060p) | 128d | 2011-04-01 | 2011-09-30 | 9-110M FS+120d | 48d | 0d | SCIENTIST [82.58 h] | 5,650.95 | CHUDAKOV | 1 | 1 | D | EUGENE C | 11-006 | 11-026 | 12-001 |  |  |  |  |  |  |  |
| 1532060a |  | Plan Experiment Controls Display management FY11 | 128d | 2011-04-01 | 2011-09-30 | 9-110M FS+120d | 157d | 0d | SCIENTIST [61.94 h] | 4,238.55 | CHUDAKOV | 1 | 1 | D | EUGENE C | 11-006 | 11-026 | 12-001 | 12-021F |  |  |  |  |  |  |
| 1532060b |  | Plan Experiment Controls Backup/Restore FY11 | 128d | 2011-04-01 | 2011-09-30 | 9-110M FS+120d | 247d | 0d | SCIENTIST [61.94 h] | 4,238.55 | CHUDAKOV | 1 | 1 | D | EUGENE C | 11-006 | 11-026 | 12-001 | 12-021F |  |  |  |  |  |  |
| 1532060c |  | Plan Experiment Controls Magnet PS FY11 | 128d | 2011-04-01 | 2011-09-30 | 9-110M FS+120d | 247d | 0d | SCIENTIST [82.58 h] | 5,650.95 | CHUDAKOV | 1 | 1 | D | EUGENE C | 11-006 | 11-026 | 12-001 | 12-021F |  |  |  |  |  |  |
| 1532060d |  | Plan Experiment Controls HV FY11 | 128d | 2011-04-01 | 2011-09-30 | 9-110M FS+120d | 20d | 0d | SCIENTIST [61.94 h] | 4,238.55 | CHUDAKOV | 1 | 1 | D | EUGENE C | 11-006 | 11-026 | 12-001 | 12-021F |  |  |  |  |  |  |
| 1532060f |  | Plan Experiment Controls LV FY11 | 128d | 2011-04-01 | 2011-09-30 | 9-110M FS+120d | 20d | 0d | SCIENTIST [82.58 h] | 5,650.95 | CHUDAKOV | 1 | 1 | D | EUGENE C | 11-006 | 11-026 | 12-001 | 12-021F |  |  |  |  |  |  |
| 1532060g |  | Plan Experiment Controls Motors FY11 | 128d | 2011-04-01 | 2011-09-30 | 9-110M FS+120d | 20d | 0d | SCIENTIST [82.58 h] | 5,650.95 | CHUDAKOV | 1 | 1 | D | EUGENE C | 11-006 | 11-026 | 12-001 |  |  |  |  |  |  |  |
| 1532060h |  | Plan Experiment Controls Gas Systems FY11 | 128d | 2011-04-01 | 2011-09-30 | 9-110M FS+120d | 247d | 0d | SCIENTIST [82.58 h] | 5,650.95 | CHUDAKOV | 1 | 1 | D | EUGENE C | 11-006 | 11-026 | 12-001 | 12-021F |  |  |  |  |  |  |
| 1532060j |  | Plan Experiment Controls Temperature FY11 | 128d | 2011-04-01 | 2011-09-30 | 9-110M FS+120d | 247d | 0d | SCIENTIST [82.58 h] | 5,650.95 | CHUDAKOV | 1 | 1 | D | EUGENE C | 11-006 | 11-026 | 12-001 | 12-021F |  |  |  |  |  |  |
| 1532060k |  | Plan Experiment Controls Target FY11 | 128d | 2011-04-01 | 2011-09-30 | 9-110M FS+120d | 227d | 0d | SCIENTIST [103.23 h] | 7,064.03 | CHUDAKOV | 1 | 1 | D | EUGENE C | 11-006 | 11-026 | 12-001 | 12-021F |  |  |  |  |  |  |
| 1532060n |  | Plan Experiment Controls Interface with DAQ FY11 | 128d | 2011-04-01 | 2011-09-30 | 9-110M FS+120d | 20d | 0d | SCIENTIST [61.94 h] | 4,238.55 | CHUDAKOV | 1 | 1 | D | EUGENE C | 11-006 | 11-026 | 12-001 |  |  |  |  |  |  |  |
| 1532035 |  | Plan Monitoring Framework FY11(FY12 @ 1532035h) | 86d | 2011-06-01 | 2011-09-30 | 9-110M FS+162d | 180d | 0d | SCIENTIST [82.89 h] | 5,672.16 | CHUDAKOV | 1 | 1 | D | EUGENE C | 11-006 | 11-026 | 12-001 | 12-021F | 12-054F |  |  |  |  |  |
| 1532035a |  | Plan Monitoring Scalers FY11 | 86d | 2011-06-01 | 2011-09-30 | 9-110M FS+162d | 379d | 0d | SCIENTIST [41.45 h] | 2,836.42 | CHUDAKOV | 1 | 1 | D | EUGENE C | 11-006 | 11-026 | 12-001 | 12-021F | 12-054F |  |  |  |  |  |
| 1532035b |  | Plan Monitoring Histograms FY11 | 86d | 2011-06-01 | 2011-09-30 | 9-110M FS+162d | 290d | 0d | SCIENTIST [55.26 h] | 3,781.44 | CHUDAKOV | 1 | 1 | D | EUGENE C | 11-006 | 11-026 | 12-001 | 12-021F | 12-054F |  |  |  |  |  |
| 1532035c |  | Plan Monitoring Remote FY11 | 86d | 2011-06-01 | 2011-09-30 | 9-110M FS+162d | 284d | 0d | SCIENTIST [41.45 h] | 2,836.42 | CHUDAKOV | 1 | 1 | D | EUGENE C | 11-006 | 11-026 | 12-001 | 12-021F | 12-054F |  |  |  |  |  |
| 1532035d |  | Plan Monitoring Hardware Status FY11 | 86d | 2011-06-01 | 2011-09-30 | 9-110M FS+162d | 290d | 0d | SCIENTIST [55.26 h] | 3,781.44 | CHUDAKOV | 1 | 1 | D | EUGENE C | 11-006 | 11-026 | 12-001 | 12-021F | 12-054F |  |  |  |  |  |
| 1532035f |  | Plan Monitoring Process Status FY11 | 86d | 2011-06-01 | 2011-09-30 | 9-110M FS+162d | 379d | 0d | SCIENTIST [41.45 h] | 2,836.42 | CHUDAKOV | 1 | 1 | D | EUGENE C | 11-006 | 11-026 | 12-001 | 12-021F | 12-054F |  |  |  |  |  |
| 1532035g |  | Plan Monitoring Trigger FY11 | 86d | 2011-06-01 | 2011-09-30 | 9-110M FS+162d | 183d | 0d | SCIENTIST [27.63 h] | 1,890.72 | CHUDAKOV | 1 | 1 | D | EUGENE C | 11-006 | 11-026 | 12-001 | 12-021F | 12-054F |  |  |  |  |  |
| 1532011E |  | FY11 Travel (ONLINE COMP) | 64d | 2011-07-01 | 2011-09-30 | 9-110M FS+184d | 20d | 0d | TRAVEL | 385.51 | CHUDAKOV | 1 | 1 | D | EUGENE C |  | 11-026 |  |  |  | 07-024 |  |  |  |  |
| 1532050 |  | Plan Event Display FY11 | 64d | 2011-07-01 | 2011-09-30 | 9-110M FS+184d | 20d | 0d | SCIENTIST [28.29 h]; CONTRB UNIV LBR [155.58 h] | 1,935.88 | CHUDAKOV | 1 | 1 | D | EUGENE C | 11-006 | 11-026 | 12-001 |  |  |  |  |  |  |  |
| 1532065 |  | Trigger Board Initialization FY11 | 64d | 2011-07-01 | 2011-09-30 | 9-110M FS+184d | 20d | 0d | COMP SCIENT [51.89 h]; SCIENTIST [134.92 h] | 12,532.27 | CHUDAKOV | 1 | 1 | D | EUGENE C | 11-006 | 11-026 | 12-001 | 12-021F | 12-054F |  |  |  |  |  |
| 1532067 |  | Level 1 Trigger Verification/debugging FY11 | 64d | 2011-07-01 | 2011-09-30 | 9-110M FS+184d | 20d | 0d | SCIENTIST [71.11 h]; COMP SCIENT [71.11 h] | 9,387.94 | CHUDAKOV | 1 | 1 | D | EUGENE C | 11-006 | 11-026 | 12-001 | 12-021F |  |  |  |  |  |  |
| 1532025 |  | Plan Front-End Software FY11 | 44d | 2011-08-01 | 2011-09-30 | 9-110M FS+204d | 207d | 0d | SCIENTIST [157.83 h] | 10,800.31 | CHUDAKOV | 1 | 1 | D | EUGENE C | 11-006 | 11-026 | 12-001 | 12-021F |  |  |  |  |  |  |
| 1532030 |  | Plan DAQ Software Event Unblocking FY11 (FY12 @ 1532030d) | 44d | 2011-08-01 | 2011-09-30 | 9-110M FS+204d | 235d | 0d | SCIENTIST [86.09 h] | 5,891.14 | CHUDAKOV | 1 | 1 | D | EUGENE C | 11-006 | 11-026 | 12-001 | 12-021F | 12-054F |  |  |  |  |  |
| 1532030a |  | Plan DAQ Software Scripts FY11 | 44d | 2011-08-01 | 2011-09-30 | 9-110M FS+204d | 145d | 0d | SCIENTIST [57.39 h] | 3,927.2 | CHUDAKOV | 1 | 1 | D | EUGENE C | 11-006 | 11-026 | 12-001 | 12-021F | 12-054F |  |  |  |  |  |
| 1532030b |  | Plan DAQ Software Run Control FY11 | 44d | 2011-08-01 | 2011-09-30 | 9-110M FS+204d | 135d | 0d | SCIENTIST [47.83 h] | 3,273.01 | CHUDAKOV | 1 | 1 | D | EUGENE C | 11-006 | 11-026 | 12-001 |  | 12-054F |  |  |  |  |  |
| 1532030c |  | Plan DAQ Software Code Management FY11 | 44d | 2011-08-01 | 2011-09-30 | 9-110M FS+204d | 234d | 0d | SCIENTIST [38.26 h] | 2,618.13 | CHUDAKOV | 1 | 1 | D | EUGENE C | 11-006 | 11-026 | 12-001 | 12-021F | 12-054F |  |  |  |  |  |
| 1532010 |  | Proc L3 Farm infrastructure PR | 58d | 2011-10-03 | 2011-12-30 | 1233040M, 9-120M | 347d | 289d | COMP SCIENT [80 h]; SCIENTIST [80 h] | 10,898.4 | CHUDAKOV | 1 | 1 | D | EUGENE C | 11-006 | 11-026 |  | 12-021F | 12-054F | 07-024 | 07-027 | 531 |  |  |
| 1532012E |  | FY12 Travel (ONLINE COMP) FY12 | 247d | 2011-10-03 | 2012-09-28 | 1532011E | 20d | 0d | TRAVEL | 1,541.63 | CHUDAKOV | 1 | 1 | D | EUGENE C | 11-006 | 11-026 |  |  |  | 07-024 |  |  | 12-053 |  |
| 1532025a |  | Plan Front-End Software FY12 | 140d | 2011-10-03 | 2012-04-27 | 1532025 | 207d | 187d | SCIENTIST [502.17 h] | 35,458.22 | CHUDAKOV | 1 | 1 | D | EUGENE C | 11-006 | 11-026 | 12-001 | 12-021F |  |  |  |  |  |  |
| 1532030aa |  | Plan DAQ Software Scripts FY12 | 140d | 2011-10-03 | 2012-04-27 | 1532030a | 145d | 23d | SCIENTIST [182.61 h] | 12,894.09 | CHUDAKOV | 1 | 1 | D | EUGENE C | 11-006 | 11-026 | 12-001 | 12-021F | 12-054F |  |  |  |  |  |
| 1532030ba |  | Plan DAQ Software Run Control FY12 | 140d | 2011-10-03 | 2012-04-27 | 1532030b | 135d | 0d | SCIENTIST [152.17 h] | 10,744.72 | CHUDAKOV | 1 | 1 | D | EUGENE C | 11-006 | 11-026 | 12-001 |  | 12-054F |  |  |  |  |  |
| 1532030ca |  | Plan DAQ Software Code Management FY12 | 140d | 2011-10-03 | 2012-04-27 | 1532030c | 234d | 117d | SCIENTIST [121.74 h] | 8,596.06 | CHUDAKOV | 1 | 1 | D | EUGENE C | 11-006 | 11-026 | 12-001 | 12-021F | 12-054F |  |  |  |  |  |
| 1532030d |  | Plan DAQ Software Event Unblocking FY12 (FY11 @ 1532030) | 140d | 2011-10-03 | 2012-04-27 | 1532030 | 235d | 187d | SCIENTIST [273.91 h] | 19,340.79 | CHUDAKOV | 1 | 1 | D | EUGENE C | 11-006 | 11-026 | 12-001 | 12-021F | 12-054F |  |  |  |  |  |
| 1532035aa |  | Plan Monitoring Scalers FY12 | 163d | 2011-10-03 | 2012-05-31 | 1532035a | 379d | 84d | SCIENTIST [78.55 h] | 5,546.42 | CHUDAKOV | 1 | 1 | D | EUGENE C | 11-006 | 11-026 | 12-001 | 12-021F | 12-054F |  |  |  |  |  |
| 1532035ba |  | Plan Monitoring Histograms FY12 | 163d | 2011-10-03 | 2012-05-31 | 1532035b | 290d | 0d | SCIENTIST [104.74 h] | 7,395.69 | CHUDAKOV | 1 | 1 | D | EUGENE C | 11-006 | 11-026 | 12-001 | 12-021F | 12-054F |  |  |  |  |  |
| 1532035ca |  | Plan Monitoring Remote FY12 | 163d | 2011-10-03 | 2012-05-31 | 1532035c | 284d | 184d | SCIENTIST [78.55 h] | 5,546.42 | CHUDAKOV | 1 | 1 | D | EUGENE C | 11-006 | 11-026 | 12-001 | 12-021F | 12-054F |  |  |  |  |  |
| 1532035da |  | Plan Monitoring Hardware Status FY12 | 163d | 2011-10-03 | 2012-05-31 | 1532035d | 290d | 0d | SCIENTIST [104.74 h] | 7,395.69 | CHUDAKOV | 1 | 1 | D | EUGENE C | 11-006 | 11-026 | 12-001 | 12-021F | 12-054F |  |  |  |  |  |
| 1532035fa |  | Plan Monitoring Process Status FY12 | 163d | 2011-10-03 | 2012-05-31 | 1532035f | 379d | 163d | SCIENTIST [78.55 h] | 5,546.42 | CHUDAKOV | 1 | 1 | D | EUGENE C | 11-006 | 11-026 | 12-001 | 12-021F | 12-054F |  |  |  |  |  |
| 1532035ga |  | Plan Monitoring Trigger FY12 | 163d | 2011-10-03 | 2012-05-31 | 1532035g | 183d | 163d | SCIENTIST [52.37 h] | 3,697.85 | CHUDAKOV | 1 | 1 | D | EUGENE C | 11-006 | 11-026 | 12-001 | 12-021F | 12-054F |  |  |  |  |  |
| 1532035h |  | Plan Monitoring Framework FY12 (FY11 @ 1532035) | 163d | 2011-10-03 | 2012-05-31 | 1532035 | 180d | 0d | SCIENTIST [157.11 h] | 11,093.54 | CHUDAKOV | 1 | 1 | D | EUGENE C | 11-006 | 11-026 | 12-001 | 12-021F | 12-054F |  |  |  |  |  |
| 1532040 |  | Plan Alarm Sys | 181d | 2011-10-03 | 2012-06-27 | 9-120M | 165d | 145d | SCIENTIST [220 h]; CONTRB UNIV LBR [220 h] | 15,534.2 | CHUDAKOV | 1 | 1 | D | EUGENE C | 11-006 | 11-026 |  | 12-021F | 12-054F |  |  |  |  |  |
| 1532045 |  | Plan Archiving DAQ Configuration | 160d | 2011-10-03 | 2012-05-25 | 9-120M | 209d | 187d | SCIENTIST [120 h] | 8,473.2 | CHUDAKOV | 1 | 1 | D | EUGENE C | 11-006 | 11-026 |  | 12-021F |  |  |  |  |  |  |
| 1532045a |  | Plan Archiving Run Info | 160d | 2011-10-03 | 2012-05-25 | 9-120M | 207d | 187d | SCIENTIST [200 h] | 14,122 | CHUDAKOV | 1 | 1 | D | EUGENE C | 11-006 | 11-026 |  | 12-021F |  |  |  |  |  |  |
| 1532045b |  | Plan Archiving Controls | 160d | 2011-10-03 | 2012-05-25 | 9-120M | 207d | 187d | SCIENTIST [200 h] | 14,122 | CHUDAKOV | 1 | 1 | D | EUGENE C | 11-006 | 11-026 |  | 12-021F |  |  |  |  |  |  |
| 1532050a |  | Plan Event Display FY12 | 117d | 2011-10-03 | 2012-03-27 | 1532050 | 20d | 0d | SCIENTIST [51.71 h]; CONTRB UNIV LBR [284.42 h] | 3,651.24 | CHUDAKOV | 1 | 1 | D | EUGENE C | 11-006 | 11-026 | 12-001 |  |  |  |  |  |  |  |
| 1532055 |  | Plan Storage Mngmnt | 120d | 2011-10-03 | 2012-03-30 | 9-120M | 247d | 227d | COMP SCIENT [352 h]; SCIENTIST [100 h] | 30,159.24 | CHUDAKOV | 1 | 1 | D | EUGENE C | 11-006 | 11-026 |  | 12-021F |  |  |  |  |  |  |
| 1532060aa |  | Plan Experiment Controls Display management FY12 | 120d | 2011-10-03 | 2012-03-30 | 1532060a | 157d | 137d | SCIENTIST [58.06 h] | 4,099.62 | CHUDAKOV | 1 | 1 | D | EUGENE C | 11-006 | 11-026 | 12-001 | 12-021F |  |  |  |  |  |  |
| 1532060ba |  | Plan Experiment Controls Backup/Restore FY12 | 120d | 2011-10-03 | 2012-03-30 | 1532060b | 247d | 227d | SCIENTIST [58.06 h] | 4,099.62 | CHUDAKOV | 1 | 1 | D | EUGENE C | 11-006 | 11-026 | 12-001 | 12-021F |  |  |  |  |  |  |
| 1532060ca |  | Plan Experiment Controls Magnet PS FY12 | 120d | 2011-10-03 | 2012-03-30 | 1532060c | 247d | 227d | SCIENTIST [77.42 h] | 5,466.63 | CHUDAKOV | 1 | 1 | D | EUGENE C | 11-006 | 11-026 | 12-001 | 12-021F |  |  |  |  |  |  |
| 1532060da |  | Plan Experiment Controls HV FY12 | 120d | 2011-10-03 | 2012-03-30 | 1532060d | 20d | 0d | SCIENTIST [58.06 h] | 4,099.62 | CHUDAKOV | 1 | 1 | D | EUGENE C | 11-006 | 11-026 | 12-001 | 12-021F |  |  |  |  |  |  |
| 1532060fa |  | Plan Experiment Controls LV FY12 | 120d | 2011-10-03 | 2012-03-30 | 1532060f | 20d | 0d | SCIENTIST [77.42 h] | 5,466.63 | CHUDAKOV | 1 | 1 | D | EUGENE C | 11-006 | 11-026 | 12-001 | 12-021F |  |  |  |  |  |  |
| 1532060ga |  | Plan Experiment Controls Motors FY12 | 120d | 2011-10-03 | 2012-03-30 | 1532060g | 20d | 0d | SCIENTIST [77.42 h] | 5,466.63 | CHUDAKOV | 1 | 1 | D | EUGENE C | 11-006 | 11-026 | 12-001 |  |  |  |  |  |  |  |
| 1532060ha |  | Plan Experiment Controls Gas Systems FY12 | 120d | 2011-10-03 | 2012-03-30 | 1532060h | 247d | 227d | SCIENTIST [77.42 h] | 5,466.63 | CHUDAKOV | 1 | 1 | D | EUGENE C | 11-006 | 11-026 | 12-001 | 12-021F |  |  |  |  |  |  |
| 1532060ja |  | Plan Experiment Controls Temperature FY12 | 120d | 2011-10-03 | 2012-03-30 | 1532060j | 247d | 227d | SCIENTIST [77.42 h] | 5,466.63 | CHUDAKOV | 1 | 1 | D | EUGENE C | 11-006 | 11-026 | 12-001 | 12-021F |  |  |  |  |  |  |
| 1532060ka |  | Plan Experiment Controls Target FY12 | 120d | 2011-10-03 | 2012-03-30 | 1532060k | 227d | 207d | SCIENTIST [96.77 h] | 6,832.93 | CHUDAKOV | 1 | 1 | D | EUGENE C | 11-006 | 11-026 | 12-001 | 12-021F |  |  |  |  |  |  |
| 1532060na |  | Plan Experiment Controls Interface with DAQ FY12 | 120d | 2011-10-03 | 2012-03-30 | 1532060n | 20d | 0d | SCIENTIST [58.06 h] | 4,099.62 | CHUDAKOV | 1 | 1 | D | EUGENE C | 11-006 | 11-026 | 12-001 |  |  |  |  |  |  |  |
| 1532060p |  | Plan Experiment Controls Framework FY12 (FY11 @ 1532060) | 120d | 2011-10-03 | 2012-03-30 | 1532060 | 48d | 0d | SCIENTIST [77.42 h] | 5,466.63 | CHUDAKOV | 1 | 1 | D | EUGENE C | 11-006 | 11-026 | 12-001 |  |  |  |  |  |  |  |
| 1532065a |  | Trigger Board Initialization FY12 Part A (Hall D grp and CODA grp) | 78d | 2011-10-03 | 2012-01-31 | 1532065 | 20d | 0d | COMP SCIENT [63.24 h]; SCIENTIST [164.43 h] | 15,760.21 | CHUDAKOV | 1 | 1 | D | EUGENE C | 11-006 | 11-026 | 12-001 | 12-021 | 12-054F |  |  |  |  |  |
| 1532067a |  | Level 1 Trigger Verification/debugging FY12 Part A | 78d | 2011-10-03 | 2012-01-31 | 1532067 | 20d | 0d | SCIENTIST [86.67 h]; COMP SCIENT [86.67 h] | 11,807.06 | CHUDAKOV | 1 | 1 | D | EUGENE C | 11-006 | 11-026 | 12-001 | 12-021 |  |  |  |  |  |  |
| 1532005 |  | Proc Trigger Testbed Electrnc's PR | 62d | 2012-01-03 | 2012-03-30 | 9-120M FS+58d | 223d | 127d | SCIENTIST [120 h] | 8,473.2 | CHUDAKOV | 1 | 1 | D | EUGENE C | 11-006 | 11-026 |  | 12-021F |  | 07-024 | 07-027 | 531 |  |  |
| 1532065b |  | Trigger Board Initialization FY12 Part B (Hall D grp and CODA grp) | 169d | 2012-02-01 | 2012-09-28 | 1532065a | 20d | 0d | COMP SCIENT [60.55 h]; SCIENTIST [157.42 h] | 15,088.72 | CHUDAKOV | 1 | 1 | D | EUGENE C | 11-006 | 11-026 | 12-001 | 12-021 | 12-054F |  |  |  |  |  |
| 1532067b |  | Level 1 Trigger Verification/debugging FY12 Part B | 169d | 2012-02-01 | 2012-09-28 | 1532067a | 20d | 0d | SCIENTIST [84.4 h]; COMP SCIENT [84.4 h] | 11,497.81 | CHUDAKOV | 1 | 1 | D | EUGENE C | 11-006 | 11-026 | 12-001 | 12-021 |  |  |  |  |  |  |
| 1532095 |  | Write Event Display FY12 | 130d | 2012-03-28 | 2012-09-28 | 9-120M, 1532050a | 20d | 0d | CONTRB UNIV LBR [1040 h] |  | CHUDAKOV | 1 | 1 | D | EUGENE C | 11-006 | 11-026 |  |  |  |  |  |  | 12-053 |  |
| 1532105 |  | Write Experiment Control Framework FY12 (FY13 @ 1532105s) | 127d | 2012-04-02 | 2012-09-28 | 1531240, 1532060p | 48d | 0d | SCIENTIST [147.78 h] | 10,434.75 | CHUDAKOV | 1 | 1 | D | EUGENE C | 11-006 | 11-026 |  | 12-021 |  |  |  |  | 12-053 |  |
| 1532105g |  | Write Experiment Control Motors FY12 | 127d | 2012-04-02 | 2012-09-28 | 1532060ga | 20d | 0d | SCIENTIST [184.73 h]; CONTRB UNIV LBR [92.36 h] | 13,043.79 | CHUDAKOV | 1 | 1 | D | EUGENE C | 11-006 | 11-026 |  | 12-021 |  |  |  |  | 12-053 |  |
| 1532105n |  | Write Experiment Control Interface with DAQ FY12 | 127d | 2012-04-02 | 2012-09-28 | 1532060na | 20d | 0d | SCIENTIST [73.89 h] | 5,217.37 | CHUDAKOV | 1 | 1 | D | EUGENE C | 11-006 | 11-026 |  | 12-021 |  |  |  |  | 12-053 |  |
| 1532075b |  | Write DAQ Software Run Control FY12 | 107d | 2012-04-30 | 2012-09-28 | 1532030ba | 135d | 0d | SCIENTIST [124.51 h] | 8,791.65 | CHUDAKOV | 1 | 1 | D | EUGENE C | 11-006 | 11-026 |  | 12-021 | 12-054F |  |  |  | 12-053 | IPL |
| 1532075a |  | Write DAQ Software Scripts FY12 | 84d | 2012-06-01 | 2012-09-28 | 9-120M FS+163d, 1532030aa | 122d | 100d | SCIENTIST [160 h] | 11,297.6 | CHUDAKOV | 1 | 1 | D | EUGENE C | 11-006 | 11-026 |  | 12-021 | 12-054F |  |  |  |  | IPL |

Notes:
- 1532075b: Explanation: IPL from 6 GeV 571130
- 1532075a: Explanation: IPL from 6 GeV 571130

| ID | Activity | Duration | Start | Finish | Predecessors | Total float | Free float | Calendar | Resources | Cost | RESP - Responsibility | STRT%COMP for CM EVM | FNSH%COMP for CM EVM | HALL D Related Milestones | CAM RESPONSIBLE | CR 11-006 | CR 11-026 | CR 12-021 | CR 12-054 | CR 12-053 | CR 07-024 | CR 07-027 | 12 GEV MAJOR PROCUREMENT CATAGORY | CR 12-055 | CR 12-001 | CR 13-014 | Inter Project Link (IPL) | ReBaseline Actuals Adjustment | Original Activity ID Rebaseline | Over Under Fixed | EVMS Reporting Codes | CR 13-007 | BOE Expenses | CR 13-015 | Post Rebaseline | Obligated Prior to Rebaseline | BOE Labor | CR 12-040 | CR 14-001 |
| --- | --- | --- | --- | --- | --- | --- | --- | --- | --- | --- | --- | --- | --- | --- | --- | --- | --- | --- | --- | --- | --- | --- | --- | --- | --- | --- | --- | --- | --- | --- | --- | --- | --- | --- | --- | --- | --- | --- | --- |
| 1532080 | Write Monitoring Framework FY12 | 64d | 2012-06-01 | 2012-08-30 | 1532035h, 9-120M | 180d | 160d |  | SCIENTIST [128 h]; CONTRB UNIV LBR [120 h] | 9,038.08 | CHUDAKOV | 1 | 1 | D | EUGENE C | 11-006 | 11-026 | 12-021 | 12-054F |  |  |  |  |  |  |  |  |  |  |  |  |  |  |  |  |  |  |  |  |
| 1532080b | Write Monitoring Histograms FY12 | 84d | 2012-06-01 | 2012-09-28 | 1532035ba | 290d | 0d |  | SCIENTIST [73.31 h]; CONTRB UNIV LBR [122.18 h] | 5,176.42 | CHUDAKOV | 1 | 1 | D | EUGENE C | 11-006 | 11-026 | 12-021 | 12-054F | 12-053 |  |  |  |  |  |  |  |  |  |  |  |  |  |  |  |  |  |  |  |
| 1532080d | Write Monitoring Hardware Status FY12 | 84d | 2012-06-01 | 2012-09-28 | 1532035da | 290d | 0d |  | SCIENTIST [48.87 h] | 3,450.71 | CHUDAKOV | 1 | 1 | D | EUGENE C | 11-006 | 11-026 | 12-021 | 12-054F | 12-053 |  |  |  |  |  |  |  |  |  |  |  |  |  |  |  |  |  |  |  |
| 1532105d | Write Experiment Control HV FY12 | 42d | 2012-08-01 | 2012-09-28 | 1532060da FS+85d | 20d | 0d |  | CONTRB UNIV LBR [112.94 h]; SCIENTIST [158.12 h] | 11,164.85 | CHUDAKOV | 1 | 1 | D | EUGENE C | 11-006 | 11-026 | 12-021 |  | 12-053 |  |  |  |  |  |  |  |  |  |  |  |  |  |  |  |  |  |  |  |
| 1532105f | Write Experiment Control LV FY12 | 42d | 2012-08-01 | 2012-09-28 | 1532060fa FS+85d | 20d | 0d |  | SCIENTIST [135.53 h] | 9,569.77 | CHUDAKOV | 1 | 1 | D | EUGENE C | 11-006 | 11-026 | 12-021 |  | 12-053 |  |  |  |  |  |  |  |  |  |  |  |  |  |  |  |  |  |  |  |
| 1532007 | Proc Trigger Testbed Electrnc's (coordinate with Hovanes) Part A | 93d | 2012-10-01 | 2013-02-20 | 9-130M, 1532005 | 96d | 22d |  | PROCUREMENT<$50K 60 | 24,765.6 | CHUDAKOV | 1 | 1 | D | EUGENE C | 11-006 | 11-026 | 12-021 |  |  | 07-024 | 07-027 | 531 | 12-055 |  |  |  |  |  |  |  |  |  |  |  |  |  |  |  |
| 1532007a | Proc Trigger Testbed Electrnc's (coordinate with Hovanes) Part B | 93d | 2012-10-01 | 2013-02-20 | 9-130M, 1532005 | 96d | 22d |  | PROCUREMENT<$50K 60 | 47,467.4 | CHUDAKOV | 1 | 1 | D | EUGENE C | 11-006 | 11-026 | 12-021 |  |  | 07-024 | 07-027 | 531 | 12-055 |  |  |  |  |  |  |  |  |  |  |  |  |  |  |  |
| 1532012Ea | FY12 Travel (ONLINE COMP) FY13 | 1d | 2012-10-01 | 2012-10-01 | 1532012E, 1532011E | 20d | 0d |  | TRAVEL | 6.42 | CHUDAKOV | 1 | 1 | D | EUGENE C | 11-006 | 11-026 |  |  | 12-053 | 07-024 |  |  |  |  |  |  |  |  |  |  |  |  |  |  |  |  |  |  |
| 1532065c | Trigger Board Initialization FY13 (Hall D grp and CODA grp) | 228d | 2012-10-01 | 2013-08-30 | 1532065b | 20d |  |  | COMP SCIENT [65.38 h]; SCIENTIST [169.97 h] | 16,810.92 | CHUDAKOV | 1 | 1 | D | EUGENE C | 11-006 | 11-026 | 12-021 | 12-054F |  |  |  |  |  | 12-001 | 13-014 |  |  |  |  |  |  |  |  |  |  |  |  |  |
| 1532067c | Level 1 Trigger Verification/debugging FY13 | 228d | 2012-10-01 | 2013-08-30 | 1532067b | 20d |  |  | SCIENTIST [113.81 h]; COMP SCIENT [113.81 h] | 15,998.28 | CHUDAKOV | 1 | 1 | D | EUGENE C | 11-006 | 11-026 | 12-021 |  |  |  |  |  |  | 12-001 | 13-014 |  |  |  |  |  |  |  |  |  |  |  |  |  |
| 1532075ba | Write DAQ Software Run Control FY13 | 113d | 2012-10-01 | 2013-03-20 | 1532075b | 135d |  |  | SCIENTIST [131.49 h] | 9,580.36 | CHUDAKOV | 1 | 1 | D | EUGENE C | 11-006 | 11-026 | 12-021 | 12-054F | 12-053 |  |  |  |  |  |  | IPL |  |  |  |  |  |  |  |  |  |  |  |  |
| 1532080a | Write Monitoring Scalers | 121d | 2012-10-01 | 2013-04-01 | 9-130M, 1532035aa | 295d | 275d |  | SCIENTIST [192 h] | 13,989.12 | CHUDAKOV | 1 | 1 | D | EUGENE C | 11-006 | 11-026 | 12-021 | 12-054F |  |  |  |  |  |  |  |  |  |  |  |  |  |  |  |  |  |  |  |  |
| 1532080ba | Write Monitoring Histograms FY13 | 136d | 2012-10-01 | 2013-04-22 | 1532080b | 290d | 270d |  | SCIENTIST [118.69 h]; CONTRB UNIV LBR [197.82 h] | 8,647.75 | CHUDAKOV | 1 | 1 | D | EUGENE C | 11-006 | 11-026 | 12-021 | 12-054F | 12-053 |  |  |  |  |  |  |  |  |  |  |  |  |  |  |  |  |  |  |  |
| 1532080da | Write Monitoring Hardware Status FY13 | 136d | 2012-10-01 | 2013-04-22 | 1532080d | 290d | 270d |  | SCIENTIST [79.13 h] | 5,765.41 | CHUDAKOV | 1 | 1 | D | EUGENE C | 11-006 | 11-026 | 12-021 | 12-054F | 12-053 |  |  |  |  |  |  |  |  |  |  |  |  |  |  |  |  |  |  |  |
| 1532095a | Write Event Display FY13 | 90d | 2012-10-01 | 2013-02-14 | 1532095 | 20d | 0d |  | CONTRB UNIV LBR [720 h] |  | CHUDAKOV | 1 | 1 | D | EUGENE C | 11-006 | 11-026 |  |  | 12-053 |  |  |  |  |  |  |  |  |  |  |  |  |  |  |  |  |  |  |  |
| 1532105da | Write Experiment Control HV FY13 | 77d | 2012-10-01 | 2013-01-28 | 1532105d | 20d | 0d |  | SCIENTIST [289.88 h]; CONTRB UNIV LBR [207.06 h] | 21,120.66 | CHUDAKOV | 1 | 1 | D | EUGENE C | 11-006 | 11-026 | 12-021 |  | 12-053 |  |  |  |  |  |  |  |  |  |  |  |  |  |  |  |  |  |  |  |
| 1532105fa | Write Experiment Control LV FY13 | 77d | 2012-10-01 | 2013-01-28 | 1532105f | 20d | 0d |  | SCIENTIST [248.47 h] | 18,103.52 | CHUDAKOV | 1 | 1 | D | EUGENE C | 11-006 | 11-026 | 12-021 |  | 12-053 |  |  |  |  |  |  |  |  |  |  |  |  |  |  |  |  |  |  |  |
| 1532105ga | Write Experiment Control Motors FY13 | 93d | 2012-10-01 | 2013-02-20 | 1532105g | 20d | 0d |  | SCIENTIST [135.27 h]; CONTRB UNIV LBR [67.64 h] | 9,855.77 | CHUDAKOV | 1 | 1 | D | EUGENE C | 11-006 | 11-026 | 12-021 |  | 12-053 |  |  |  |  |  |  |  |  |  |  |  |  |  |  |  |  |  |  |  |
| 1532105na | Write Experiment Control Interface with DAQ FY13 | 93d | 2012-10-01 | 2013-02-20 | 1532105n | 20d | 0d |  | SCIENTIST [54.11 h] | 3,942.45 | CHUDAKOV | 1 | 1 | D | EUGENE C | 11-006 | 11-026 | 12-021 |  | 12-053 |  |  |  |  |  |  |  |  |  |  |  |  |  |  |  |  |  |  |  |
| 1532105s | Write Experiment Control Framework FY13 (FY12 @ 1532105) | 93d | 2012-10-01 | 2013-02-20 | 1532105 | 48d | 28d |  | SCIENTIST [108.22 h] | 7,884.91 | CHUDAKOV | 1 | 1 | D | EUGENE C | 11-006 | 11-026 | 12-021 |  | 12-053 |  |  |  |  |  |  |  |  |  |  |  |  |  |  |  |  |  |  |  |
| 1532013E | FY13 Travel (ONLINE COMP) | 227d | 2012-10-02 | 2013-08-30 | 1532012E, 1532012Ea | 20d |  |  | TRAVEL | 1,467.9 | CHUDAKOV | 1 | 1 | D | EUGENE C | 11-006 | 11-026 |  |  |  | 07-024 |  |  |  |  | 13-014 |  |  |  |  |  |  |  |  |  |  |  |  |  |
| 1532075c | Write DAQ Software Code Management | 121d | 2012-10-15 | 2013-04-15 | 9-130M FS+10d, 1532030ca | 117d |  |  | SCIENTIST [128 h] | 9,326.08 | CHUDAKOV | 1 | 1 | D | EUGENE C | 11-006 | 11-026 | 12-021 | 12-054F |  |  |  |  |  |  |  | IPL |  |  |  |  |  |  |  |  |  |  |  |  |
| 1532105a | Write Experiment Control Display Management | 121d | 2012-10-15 | 2013-04-15 | 9-130M FS+10d, 1532060aa | 20d | 0d |  | SCIENTIST [320 h] | 23,315.2 | CHUDAKOV | 1 | 1 | D | EUGENE C | 11-006 | 11-026 | 12-021 |  |  |  |  |  |  |  |  |  |  |  |  |  |  |  |  |  |  |  |  |  |
| 1532080f | Write Monitoring Process Status | 131d | 2013-01-31 | 2013-08-06 | 9-130M FS+79d, 1532035fa | 216d | 196d |  | SCIENTIST [192 h] | 13,989.12 | CHUDAKOV | 1 | 1 | D | EUGENE C | 11-006 | 11-026 | 12-021 | 12-054 |  |  |  |  |  |  |  |  |  |  |  |  |  |  |  |  |  |  |  |  |
| 1532080g | Write Monitoring Trigger | 149d | 2013-01-31 | 2013-08-30 | 9-130M FS+79d, 1532035ga | 20d | 0d |  | SCIENTIST [68.7 h] | 5,005.48 | CHUDAKOV | 1 | 1 | D | EUGENE C | 11-006 | 11-026 | 12-021 | 12-054 |  |  |  |  |  |  | 13-014 |  |  |  |  |  |  |  |  |  |  |  |  |  |
| 1532085 | Write Alarm Sys | 136d | 2013-01-31 | 2013-08-13 | 9-130M FS+79d, 1532040 | 20d | 0d |  | SCIENTIST [256 h]; CONTRB UNIV LBR [440 h] | 18,652.16 | CHUDAKOV | 1 | 1 | D | EUGENE C | 11-006 | 11-026 | 12-021 | 12-054 |  |  |  |  |  |  |  |  |  |  |  |  |  |  |  |  |  |  |  |  |
| 1532070 | Write Front-End Software | 120d | 2013-02-01 | 2013-07-23 | 1532025a, 9-130M FS+80d | 20d | 0d |  | SCIENTIST [608 h] | 44,298.88 | CHUDAKOV | 1 | 1 | D | EUGENE C | 11-006 | 11-026 | 12-021 |  |  |  |  |  |  |  |  |  |  |  |  |  |  |  |  |  |  |  |  |  |
| 1532075 | Write DAQ Software Event Unblocking | 120d | 2013-02-01 | 2013-07-23 | 1532030d, 9-130M FS+80d | 48d |  |  | SCIENTIST [352 h] | 25,646.72 | CHUDAKOV | 1 | 1 | D | EUGENE C | 11-006 | 11-026 | 12-021 | 12-054F |  |  |  |  |  |  |  | IPL |  |  |  |  |  |  |  |  |  |  |  |  |
| 1532105k | Write Experiment Control Target | 126d | 2013-02-01 | 2013-07-31 | 1532060ka, 9-130M FS+80d | 20d | 0d |  | SCIENTIST [320 h] | 23,315.2 | CHUDAKOV | 1 | 1 | D | EUGENE C | 11-006 | 11-026 | 12-021 |  |  |  |  |  |  |  |  |  |  |  |  |  |  |  |  |  |  |  |  |  |
| 1532010a | Proc L3 Farm infrastructure Phase 1 | 90d | 2013-03-04 | 2013-07-09 | 9-130M FS+100d, 1532010 | 58d |  |  | PROCUREMENT<$50K 60 | 13,414.7 | CHUDAKOV | 1 | 1 | D | EUGENE C | 11-006 | 11-026 | 12-021 | 12-054 |  | 07-024 | 07-027 | 531 |  |  |  |  |  |  |  |  |  |  |  |  |  |  |  |  |
| 1532077 | Write DAQ Software Scripts FY13 | 126d | 2013-03-04 | 2013-08-28 | 1532075a, 9-130M FS+100d | 22d |  |  | SCIENTIST [160 h] | 11,657.6 | CHUDAKOV | 1 | 1 | D | EUGENE C | 11-006 | 11-026 | 12-021 | 12-054F |  |  |  |  |  |  |  | IPL |  |  |  |  |  |  |  |  |  |  |  |  |
| 1532080c | Write Monitoring Remote | 126d | 2013-03-04 | 2013-08-28 | 9-130M FS+100d, 1532035ca | 100d | 80d |  | SCIENTIST [128 h]; CONTRB UNIV LBR [320 h] | 9,326.08 | CHUDAKOV | 1 | 1 | D | EUGENE C | 11-006 | 11-026 | 12-021 | 12-054F |  |  |  |  |  |  |  |  |  |  |  |  |  |  |  |  |  |  |  |  |
| 1532090 | Write Archiving DAQ Configuration | 84d | 2013-03-04 | 2013-06-28 | 1532045, 9-130M FS+100d | 22d | 2d |  | COMP SCIENT [192 h] | 13,000.32 | CHUDAKOV | 1 | 1 | D | EUGENE C | 11-006 | 11-026 | 12-021 |  |  |  |  |  |  |  |  |  |  |  |  |  |  |  |  |  |  |  |  |  |
| 1532090a | Write Archiving Run Info | 126d | 2013-03-04 | 2013-08-28 | 1532045a, 9-130M FS+100d | 20d | 0d |  | COMP SCIENT [256 h] | 17,333.76 | CHUDAKOV | 1 | 1 | D | EUGENE C | 11-006 | 11-026 | 12-021 |  |  |  |  |  |  |  |  |  |  |  |  |  |  |  |  |  |  |  |  |  |
| 1532090b | Write Archiving Controls | 126d | 2013-03-04 | 2013-08-28 | 9-130M FS+100d, 1532045b | 20d | 0d |  | COMP SCIENT [192 h] | 13,000.32 | CHUDAKOV | 1 | 1 | D | EUGENE C | 11-006 | 11-026 | 12-021 |  |  |  |  |  |  |  |  |  |  |  |  |  |  |  |  |  |  |  |  |  |
| 1532100 | Write Storage Mngmnt | 126d | 2013-03-04 | 2013-08-28 | 9-130M FS+100d, 1532055 | 20d | 0d |  | SCIENTIST [32 h]; COMP SCIENT [320 h] | 23,998.72 | CHUDAKOV | 1 | 1 | D | EUGENE C | 11-006 | 11-026 | 12-021 |  |  |  |  |  |  |  |  |  |  |  |  |  |  |  |  |  |  |  |  |  |
| 1532105b | Write Experiment Control Display Backup/Restore | 63d | 2013-03-04 | 2013-05-30 | 1532060ba, 9-130M FS+100d | 20d | 0d |  | SCIENTIST [96 h] | 6,994.56 | CHUDAKOV | 1 | 1 | D | EUGENE C | 11-006 | 11-026 | 12-021 |  |  |  |  |  |  |  |  |  |  |  |  |  |  |  |  |  |  |  |  |  |
| 1532105c | Write Experiment Control Magnet PS | 126d | 2013-03-04 | 2013-08-28 | 9-130M FS+100d, 1532060ca | 20d | 0d |  | SCIENTIST [320 h] | 23,315.2 | CHUDAKOV | 1 | 1 | D | EUGENE C | 11-006 | 11-026 | 12-021 |  |  |  |  |  |  |  |  |  |  |  |  |  |  |  |  |  |  |  |  |  |
| 1532105h | Write Experiment Control Gas Systems | 126d | 2013-03-04 | 2013-08-28 | 1532060ha, 9-130M FS+100d | 20d | 0d |  | CONTRB UNIV LBR [160 h]; SCIENTIST [320 h] | 23,315.2 | CHUDAKOV | 1 | 1 | D | EUGENE C | 11-006 | 11-026 | 12-021 |  |  |  |  |  |  |  |  |  |  |  |  |  |  |  |  |  |  |  |  |  |
| 1532105j | Write Experiment Control Temerature | 126d | 2013-03-04 | 2013-08-28 | 9-130M FS+100d, 1532060ja | 20d | 0d |  | SCIENTIST [256 h] | 18,652.16 | CHUDAKOV | 1 | 1 | D | EUGENE C | 11-006 | 11-026 | 12-021 |  |  |  |  |  |  |  |  |  |  |  |  |  |  |  |  |  |  |  |  |  |
| 1532082 | Write Monitoring Framework FY13 | 88d | 2013-04-29 | 2013-08-30 | 9-130M FS+140d, 1532080 | 20d | 0d |  | SCIENTIST [108.31 h]; CONTRB UNIV LBR [101.54 h] | 7,891.44 | CHUDAKOV | 1 | 1 | D | EUGENE C | 11-006 | 11-026 | 12-021 | 12-054 |  |  |  |  |  |  | 13-014 |  |  |  |  |  |  |  |  |  |  |  |  |  |
| 1532015 | Install L3 Farm infrastructure | 38d | 2013-07-10 | 2013-08-30 | 9-130M FS+190d | 20d |  |  | COMP SCIENT [118.44 h]; SCIENTIST [39.48 h] | 10,896.08 | CHUDAKOV | 1 | 1 | D | EUGENE C | 11-006 | 11-026 | 12-021 | 12-054 |  |  |  |  |  |  | 13-014 |  |  |  |  |  |  |  |  |  |  |  |  |  |
| 1532210 | Re-Baseline Actuals Adjustment | 1d | 2013-08-30 | 2013-08-30 | 9-130M FS+227d | 20d |  |  | PROCUREMENT>$50K 69 NO ESCALATION | -554,366.53 | CHUDAKOV | 1 | 1 |  | EUGENE C |  |  |  |  |  |  |  |  |  |  | 13-014 |  | ADJ |  |  |  |  |  |  |  |  |  |  |  |
| 2532000 | Purchased Labor (Sergey) | 20d | 2013-09-03 | 2013-09-30 | 9-130M FS+228d | 247d |  | 8/5 M-F w/JLAB Holidays ReBaseline | PROCUREMENT<$50K 60 | 1,572.8 | CHUDAKOV | 1 | 1 | D | EUGENE C | 11-006 | 11-026 |  |  |  | 07-024 |  |  |  |  |  |  |  | 2532013E | y | E | 13-007F | PE | 13-015 | PR | OB |  |  |  |
| 2532005 | Install OS system along with network 9settings FY13 | 20d | 2013-09-03 | 2013-09-30 | 9-130M FS+228d | 81.25d | 0d | 8/5 M-F w/JLAB Holidays ReBaseline | SR STAFF [11.43 h] | 1,332.74 | CHUDAKOV | 1 | 1 | D | EUGENE C | 11-006 | 11-026 | 12-021 | 12-054 |  | 07-024 | 07-027 | 531 |  |  |  |  |  | 2532005 |  | S | 13-007 |  | 13-015 | PR |  | EJ |  |  |
| 2532013E | FY13 Travel (ONLINE COMP) | 20d | 2013-09-03 | 2013-09-30 | 9-130M FS+228d | 501d | 0d | 8/5 M-F w/JLAB Holidays ReBaseline | TRAVEL | 129.3 | CHUDAKOV | 1 | 1 | D | EUGENE C | 11-006 | 11-026 |  |  |  | 07-024 |  |  |  |  |  |  |  | 2532013E |  | E | 13-007F | PE | 13-015 | PR |  |  |  |  |
| 2532020 | Coordination of online computing setup | 20d | 2013-09-03 | 2013-09-30 | 9-130M FS+228d | 129d | 83d | 8/5 M-F w/JLAB Holidays ReBaseline | SCIENTIST [12 h] | 874.32 | CHUDAKOV | 1 | 1 | D | EUGENE C | 11-006 | 11-026 | 12-021 | 12-054 |  |  |  |  |  |  |  |  |  | 2532020 |  | E | 13-007 |  | 13-015 | PR |  | EJ |  |  |
| 2532035 | Create scripts to launch and kill: CODA system, monitoring system FY13 | 20d | 2013-09-03 | 2013-09-30 | 9-130M FS+228d | 65d | 0d | 8/5 M-F w/JLAB Holidays ReBaseline | SCIENTIST [35.96 h] | 2,620.05 | CHUDAKOV | 1 | 1 | D | EUGENE C | 11-006 | 11-026 | 12-021 | 12-054 |  |  |  |  |  |  |  |  |  | 2532035 |  | S | 13-007 |  | 13-015 | PR |  | EJ |  |  |
| 2532040 | Run bookkeeping scripts (database;data files and special events) FY13 | 20d | 2013-09-03 | 2013-09-30 | 9-130M FS+228d | 27d | 0d | 8/5 M-F w/JLAB Holidays ReBaseline | SCIENTIST [37.8 h] | 2,754.11 | CHUDAKOV | 1 | 1 | D | EUGENE C | 11-006 | 11-026 | 12-021F | 12-054F |  |  |  |  |  |  |  |  |  | 2532040 |  | S | 13-007F |  | 13-015 | PR |  | EJ |  |  |
| 2532050 | Readout Lists FY13 | 20d | 2013-09-03 | 2013-09-30 | 9-130M FS+228d | 0d |  | 8/5 M-F w/JLAB Holidays ReBaseline | SCIENTIST [31.17 h] | 2,271.05 | CHUDAKOV | 1 | 1 | D | EUGENE C | 11-006 | 11-026 | 12-021F | 12-054F |  |  |  |  |  |  |  |  |  | 2532050 |  | S | 13-007F |  | 13-015 | PR |  | EJ |  |  |
| 2532070 | Implement Translation Tables FY13 | 20d | 2013-09-03 | 2013-09-30 | 2532030 FS-118d | 65d | 0d | 8/5 M-F w/JLAB Holidays ReBaseline | SCIENTIST [9.17 h] | 668.13 | CHUDAKOV | 1 | 1 | D | EUGENE C | 11-006 | 11-026 | 12-021 |  |  |  |  |  |  |  |  |  |  | 2532070 |  | S | 13-007 |  | 13-015 | PR |  | EJ |  |  |
| 2532080 | ROOTSpy enabled Monitoring Processes FY13 | 20d | 2013-09-03 | 2013-09-30 | 2532030 FS-118d | 39d | 0d | 8/5 M-F w/JLAB Holidays ReBaseline | SCIENTIST [51.2 h] | 3,730.43 | CHUDAKOV | 1 | 1 | D | EUGENE C | 11-006 | 11-026 | 12-021 | 12-054F |  |  |  |  |  |  |  | IPL |  | 2532080 |  | S | 13-007 |  | 13-015 | PR |  | EJ |  |  |
| 2532170a | HV Controls (FDC; CDC; TOF; FCAL; HODO) Phase 2 FY13 | 20d | 2013-09-03 | 2013-09-30 | 9-130M FS+228d | 162d | 0d | 8/5 M-F w/JLAB Holidays ReBaseline | MECH TECH [30.48 h]; SCIENTIST [30.48 h] | 3,617.99 | CHUDAKOV | 1 | 1 | D | EUGENE C | 11-006 | 11-026 | 12-021 |  |  |  |  |  |  |  |  |  |  | 2532170a |  | S |  |  | 13-015 | PR |  | EJ | 12-040 |  |
| 2532175 | LV Controls (BCAl; ST; FDC) FY13 | 20d | 2013-09-03 | 2013-09-30 | 9-130M FS+228d | 0d |  | 8/5 M-F w/JLAB Holidays ReBaseline | MECH TECH [7.14 h]; SCIENTIST [5.72 h] | 744.08 | CHUDAKOV | 1 | 1 | D | EUGENE C | 11-006 | 11-026 | 12-021 |  |  |  |  |  |  |  |  |  |  | 2532175 |  | S |  |  | 13-015 | PR |  | EJ | 12-040 |  |
| 2532205 | Motors (radiator, converter, collimator, tagger) FY13 | 20d | 2013-09-03 | 2013-09-30 | 9-130M FS+228d | 20d | 0d | 8/5 M-F w/JLAB Holidays ReBaseline | MECH TECH [53.33 h]; SCIENTIST [26.67 h] | 4,388.8 | CHUDAKOV | 1 | 1 | D | EUGENE C | 11-006 | 11-026 | 12-021 |  |  |  |  |  |  |  |  |  |  | 2532205 |  | S |  |  | 13-015 | PR |  | EJ | 12-040 |  |
| 2532215 | CSS Control GUIs FY13 | 20d | 2013-09-03 | 2013-09-30 | 9-130M FS+228d | 11d | 0d | 8/5 M-F w/JLAB Holidays ReBaseline | SCIENTIST [24.81 h]; MECH TECH [37.21 h] | 3,514.05 | CHUDAKOV | 1 | 1 | D | EUGENE C | 11-006 | 11-026 | 12-021 |  |  |  |  |  |  |  |  |  |  | 2532215 |  | S |  |  | 13-015 | PR |  | EJ | 12-040 |  |
| 2532230 | Alarms (configuration,display, history) FY13 | 20d | 2013-09-03 | 2013-09-30 | 9-130M FS+228d | 83d | 0d | 8/5 M-F w/JLAB Holidays ReBaseline | SCIENTIST [71.11 h]; VISTNG USERS [213.33 h] | 9,437 | CHUDAKOV | 1 | 1 | D | EUGENE C | 11-006 | 11-026 | 12-021 |  |  |  |  |  |  |  |  |  |  | 2532230 |  | S |  |  | 13-015 | PR |  | EJ | 12-040 |  |
| 2532250 | EPICS Archving and Restoration FY13 | 20d | 2013-09-03 | 2013-09-30 | 9-130M FS+228d | 0d |  | 8/5 M-F w/JLAB Holidays ReBaseline | SCIENTIST [34.53 h] | 2,515.86 | CHUDAKOV | 1 | 1 | D | EUGENE C | 11-006 | 11-026 | 12-021 |  |  |  |  |  |  |  |  |  |  | 2532250 |  | S |  |  | 13-015 | PR |  | EJ | 12-040 |  |
| 2532005a | Install OS system along with network 9settings FY14 | 20.75d | 2013-10-01 | 2013-10-29 | 9-130M FS+228d, 2532005 | 81.25d | 21.25d | 8/5 M-F w/JLAB Holidays ReBaseline | SR STAFF [12.57 h] | 1,512.42 | CHUDAKOV | 1 | 1 | D | EUGENE C | 11-006 | 11-026 | 12-021 | 12-054 |  | 07-024 | 07-027 | 531 |  |  |  |  |  | 2532005 |  | S | 13-007 |  | 13-015 | PR |  | EJ |  | 14-001 |
| 2532014E | FY14 Travel (ONLINE COMP) | 246d | 2013-10-01 | 2014-09-29 | 2532013E | 501d |  | 8/5 M-F w/JLAB Holidays ReBaseline | TRAVEL | 1,648.18 | CHUDAKOV | 1 | 1 | D | EUGENE C | 11-006 | 11-026 |  |  |  | 07-024 |  |  |  |  |  |  |  | 2532014E |  | E | 13-007F | PE | 13-015 | PR |  |  |  | 14-001 |
| 2532035a | Create scripts to launch and kill: CODA system, monitoring system FY14 | 69d | 2013-10-01 | 2014-01-17 | 9-130M FS+228d, 2532035 | 65d |  | 8/5 M-F w/JLAB Holidays ReBaseline | SCIENTIST [124.04 h] | 9,325.33 | CHUDAKOV | 1 | 1 | D | EUGENE C | 11-006 | 11-026 | 12-021 | 12-054 |  |  |  |  |  |  |  |  |  | 2532035 |  | S | 13-007 |  | 13-015 | PR |  | EJ |  | 14-001 |
| 2532040a | Run bookkeeping scripts (database;data files and special events) FY14 | 107d | 2013-10-01 | 2014-03-13 | 2532040, 9-130M FS+228d | 27d |  | 8/5 M-F w/JLAB Holidays ReBaseline | SCIENTIST [202.2 h] | 15,201.4 | CHUDAKOV | 1 | 1 | D | EUGENE C | 11-006 | 11-026 | 12-021F | 12-054F |  |  |  |  |  |  |  |  |  | 2532040 |  | S | 13-007F |  | 13-015 | PR |  | EJ |  | 14-001 |
| 2532050a | Readout Lists FY14 | 134d | 2013-10-01 | 2014-04-21 | 9-130M FS+228d, 2532050 | 0d |  | 8/5 M-F w/JLAB Holidays ReBaseline | SCIENTIST [208.83 h] | 15,699.84 | CHUDAKOV | 1 | 1 | D | EUGENE C | 11-006 | 11-026 | 12-021F | 12-054F |  |  |  |  |  |  |  |  |  | 2532050 |  | S | 13-007F |  | 13-015 | PR |  | EJ |  | 14-001 |
| 2532070a | Implement Translation Tables FY14 | 69d | 2013-10-01 | 2014-01-17 | 2532030 FS-118d, 2532070 | 65d |  | 8/5 M-F w/JLAB Holidays ReBaseline | SCIENTIST [31.63 h] | 2,377.94 | CHUDAKOV | 1 | 1 | D | EUGENE C | 11-006 | 11-026 | 12-021 |  |  |  |  |  |  |  |  |  |  | 2532070 |  | S | 13-007 |  | 13-015 | PR |  | EJ |  | 14-001 |
| 2532080a | ROOTSpy enabled Monitoring Processes FY14 | 80d | 2013-10-01 | 2014-02-04 | 2532030 FS-118d, 2532080 | 39d | 0d | 8/5 M-F w/JLAB Holidays ReBaseline | SCIENTIST [204.8 h] | 15,396.86 | CHUDAKOV | 1 | 1 | D | EUGENE C | 11-006 | 11-026 | 12-021 | 12-054F |  |  |  |  |  |  |  | IPL |  | 2532080 |  | S | 13-007 |  | 13-015 | PR |  | EJ |  | 14-001 |
| 2532170aa | HV Controls (FDC; CDC; TOF; FCAL; HODO) Phase 2 FY14 | 85d | 2013-10-01 | 2014-02-11 | 2532170a, 9-130M FS+228d | 162d |  | 8/5 M-F w/JLAB Holidays ReBaseline | MECH TECH [129.53 h]; SCIENTIST [129.53 h] | 15,866.81 | CHUDAKOV | 1 | 1 | D | EUGENE C | 11-006 | 11-026 | 12-021 |  |  |  |  |  |  |  |  |  |  | 2532170a |  | S |  |  | 13-015 | PR |  | EJ | 12-040 | 14-001 |
| 2532175b | LV Controls (BCAl; ST; FDC) FY14 | 120d | 2013-10-01 | 2014-04-01 | 2532175, 9-130M FS+228d | 0d |  | 8/5 M-F w/JLAB Holidays ReBaseline | MECH TECH [42.86 h]; SCIENTIST [34.28 h] | 4,605.42 | CHUDAKOV | 1 | 1 | D | EUGENE C | 11-006 | 11-026 | 12-021 |  |  |  |  |  |  |  |  |  |  | 2532175 |  | S |  |  | 13-015 | PR |  | EJ | 12-040 | 14-001 |
| 2532205a | Motors (radiator, converter, collimator, tagger) FY14 | 100d | 2013-10-01 | 2014-03-04 | 9-130M FS+228d, 2532205 | 20d | 9d | 8/5 M-F w/JLAB Holidays ReBaseline | MECH TECH [266.67 h]; SCIENTIST [133.33 h] | 22,642.67 | CHUDAKOV | 1 | 1 | D | EUGENE C | 11-006 | 11-026 | 12-021 |  |  |  |  |  |  |  |  |  |  | 2532205 |  | S |  |  | 13-015 | PR |  | EJ | 12-040 | 14-001 |
| 2532215a | CSS Control GUIs FY14 | 109d | 2013-10-01 | 2014-03-17 | 9-130M FS+228d, 2532215 | 11d | 0d | 8/5 M-F w/JLAB Holidays ReBaseline | SCIENTIST [135.19 h]; MECH TECH [202.79 h] | 19,759.66 | CHUDAKOV | 1 | 1 | D | EUGENE C | 11-006 | 11-026 | 12-021 |  |  |  |  |  |  |  |  |  |  | 2532215 |  | S |  |  | 13-015 | PR |  | EJ | 12-040 | 14-001 |
| 2532230a | Alarms (configuration,display, history) FY14 | 25d | 2013-10-01 | 2013-11-04 | 9-130M FS+228d, 2532230 | 83d | 0d | 8/5 M-F w/JLAB Holidays ReBaseline | SCIENTIST [88.89 h]; VISTNG USERS [266.67 h] | 12,173.49 | CHUDAKOV | 1 | 1 | D | EUGENE C | 11-006 | 11-026 | 12-021 |  |  |  |  |  |  |  |  |  |  | 2532230 |  | S |  |  | 13-015 | PR |  | EJ | 12-040 | 14-001 |

Notes:
- 1532075ba: Explanation: IPL from 6 GeV 571130
- 1532075c: Explanation: IPL from 6 GeV 571130
- 1532075: Explanation: IPL from 6 GeV 571130
- 1532077: Explanation: IPL from 6 GeV 571130
- 2532080: Explanation: IPL from 6 GeV 571130
- 2532080a: Explanation: IPL from 6 GeV 571130

| ID | Activity | Duration | Start | Finish | Predecessors | Total float | Free float | Calendar | Resources | Cost | Original Activity ID Rebaseline | RESP - Responsibility | STRT%COMP for CM EVM | FNSH%COMP for CM EVM | HALL D Related Milestones | EVMS Reporting Codes | CAM RESPONSIBLE | CR 11-006 | CR 11-026 | CR 12-021 | CR 12-040 | BOE Labor | CR 13-015 | Post Rebaseline | CR 14-001 | CR 12-054 | CR 13-007 | Inter Project Link (IPL) |
| --- | --- | --- | --- | --- | --- | --- | --- | --- | --- | --- | --- | --- | --- | --- | --- | --- | --- | --- | --- | --- | --- | --- | --- | --- | --- | --- | --- | --- |
| 2532250a | EPICS Archving and Restoration FY14 | 119d | 2013-10-01 | 2014-03-31 | 9-130M FS+228d, 2532250 | 0d |  | 8/5 M-F w/JLAB Holidays ReBaseline | SCIENTIST [205.47 h] | 15,447.23 | 2532250 | CHUDAKOV | 1 | 1 | D | S | EUGENE C | 11-006 | 11-026 | 12-021 | 12-040 | EJ | 13-015 | PR | 14-001 |  |  |  |
| 2532055 | Write COOL Config Files | 79d | 2013-11-01 | 2014-03-06 | 2532030 FS-75d | 32d |  | 8/5 M-F w/JLAB Holidays ReBaseline | SCIENTIST [160 h] | 12,028.8 | 2532055 | CHUDAKOV | 1 | 1 | D | S | EUGENE C | 11-006 | 11-026 | 12-021F |  | EJ | 13-015 | PR | 14-001 | 12-054F | 13-007F |  |
| 2532100 | Transport from RAID to Tape Silo | 86d | 2013-11-01 | 2014-03-17 | 9-140M FS+23d | 2d | 0d | 8/5 M-F w/JLAB Holidays ReBaseline | SR STAFF [160 h] | 19,251.2 | 2532100 | CHUDAKOV | 1 | 1 | D | S | EUGENE C | 11-006 | 11-026 | 12-021 |  | EJ | 13-015 | PR | 14-001 |  | 13-007 |  |
| 2532185 | Tagger magnet and NMR control SWT (accel Grp) | 51d | 2013-11-05 | 2014-01-29 | 2562050a FS+17d, 2562050 FS+17d | 44d | 33d | 8/5 M-F w/JLAB Holidays ReBaseline | ELEC ENG; COMP SCIENT [160 h] | 11,179.2 | 2532185 | CHUDAKOV | 1 | 1 | D | S | EUGENE C | 11-006 | 11-026 | 12-021 | 12-040 | EJ | 13-015 | PR | 14-001 |  | 13-007 |  |
| 2532130 | FDC/CDC Gas Systems Controls | 43d | 2013-11-12 | 2014-01-24 | 2562392 FS+21d, 2562392a FS+21d | 47d |  | 8/5 M-F w/JLAB Holidays ReBaseline | MECH ENG [120 h] | 8,960.4 | 2532130 | CHUDAKOV | 1 | 1 | D | S | EUGENE C | 11-006 | 11-026 | 12-021 | 12-040 | EJ | 13-015 | PR | 14-001 |  | 13-007 |  |
| 2532190 | Sweeping and pair spectrometer magnet control SWT (accel Grp) | 54d | 2013-11-12 | 2014-02-10 | 2553035 FS+30d | 36d | 25d | 8/5 M-F w/JLAB Holidays ReBaseline | ELEC ENG; COMP SCIENT [80 h] | 5,589.6 | 2532190 | CHUDAKOV | 1 | 1 | D | S | EUGENE C | 11-006 | 11-026 | 12-021 | 12-040 | EJ | 13-015 | PR | 14-001 |  | 13-007 |  |
| 2532245 | DAQ monitoring Software | 125d | 2013-11-27 | 2014-06-06 | 9-140M FS+41.5d | 80.5d |  | 8/5 M-F w/JLAB Holidays ReBaseline | SCIENTIST [160 h] | 12,028.8 | 2532245 | CHUDAKOV | 1 | 1 | D | S | EUGENE C | 11-006 | 11-026 | 12-021 | 12-040 | EJ | 13-015 | PR | 14-001 |  |  |  |
| 2532015 | Database web-server wiki installations | 32d | 2013-12-02 | 2014-01-27 | 2532030 FS-56d, 2532005a, 2532005 | 60d |  | 8/5 M-F w/JLAB Holidays ReBaseline | SR STAFF [80 h] | 9,625.6 | 2532015 | CHUDAKOV | 1 | 1 | D | H | EUGENE C | 11-006 | 11-026 | 12-021 |  | PE | 13-015 | PR | 14-001 | 12-054 | 13-007 |  |
| 2532030 | Install CODA and supporting software | 56d | 2013-12-02 | 2014-02-28 | 9-140M FS+42d | 1d | 0d | 8/5 M-F w/JLAB Holidays ReBaseline | SCIENTIST [80 h] | 6,014.4 | 2532030 | CHUDAKOV | 1 | 1 | D | S | EUGENE C | 11-006 | 11-026 | 12-021 |  | PE | 13-015 | PR | 14-001 | 12-054 | 13-007 |  |
| 2532075 | Farm Process Manager | 204d | 2013-12-02 | 2014-09-29 | 2532030 FS-56d | 1d |  | 8/5 M-F w/JLAB Holidays ReBaseline | SCIENTIST [280 h] | 21,050.4 | 2532075 | CHUDAKOV | 1 | 1 | D | S | EUGENE C | 11-006 | 11-026 | 12-021 |  | EJ | 13-015 | PR | 14-001 | 12-054F | 13-007 | IPL |
| 2532115 | Archiving DAQ Configuration | 125d | 2013-12-02 | 2014-06-06 | 2532030 FS-56d | 80d |  | 8/5 M-F w/JLAB Holidays ReBaseline | SCIENTIST [160 h] | 12,028.8 | 2532115 | CHUDAKOV | 1 | 1 | D | S | EUGENE C | 11-006 | 11-026 | 12-021 |  | EJ | 13-015 | PR | 14-001 | 12-054 | 13-007 |  |
| 2532145 | Temperature/Humidity monitoring | 48d | 2013-12-02 | 2014-02-18 | 9-140M FS+42d | 30d |  | 8/5 M-F w/JLAB Holidays ReBaseline | MECH ENG [160 h] | 11,947.2 | 2532145 | CHUDAKOV | 1 | 1 | D | S | EUGENE C | 11-006 | 11-026 | 12-021 | 12-040 | EJ | 13-015 | PR | 14-001 |  | 13-007 |  |
| 2532140 | Controls for Chillers (FDC;BCAL;Target) | 68d | 2013-12-16 | 2014-04-01 | 9-140M FS+52d | 0d |  | 8/5 M-F w/JLAB Holidays ReBaseline | MECH ENG [160 h] | 11,947.2 | 2532140 | CHUDAKOV | 1 | 1 | D | S | EUGENE C | 11-006 | 11-026 | 12-021 |  | EJ | 13-015 | PR | 14-001 | 12-054 | 13-007 |  |
| 2532135 | BCAL Gas System Controls | 34d | 2014-01-02 | 2014-02-19 | 2562830 FS+37d, 2562830a FS+37d | 29d |  | 8/5 M-F w/JLAB Holidays ReBaseline | MECH ENG [80 h] | 5,973.6 | 2532135 | CHUDAKOV | 1 | 1 | D | H | EUGENE C | 11-006 | 11-026 | 12-021 | 12-040 | EJ | 13-015 | PR | 14-001 |  |  |  |
| 2532180 | BIAS Control for Microscope | 62d | 2014-01-02 | 2014-03-31 | 2531350 | 128d |  | 8/5 M-F w/JLAB Holidays ReBaseline | SCIENTIST [160 h] | 12,028.8 | 2532180 | CHUDAKOV | 1 | 1 | D | S | EUGENE C | 11-006 | 11-026 | 12-021 | 12-040 | EJ | 13-015 | PR | 14-001 |  |  |  |
| 2532155 | Cryo Target Controls | 50d | 2014-01-09 | 2014-03-20 | 9-140M FS+62d | 8d |  | 8/5 M-F w/JLAB Holidays ReBaseline | MECH ENG [200 h] | 14,934 | 2532155 | CHUDAKOV | 1 | 1 | D | S | EUGENE C | 11-006 | 11-026 | 12-021 | 12-040 | EJ | 13-015 | PR | 14-001 |  |  |  |
| 2532200 | Vacuum System Controls (accel Grp) | 37d | 2014-01-14 | 2014-03-06 | 9-140M FS+65d | 18d | 7d | 8/5 M-F w/JLAB Holidays ReBaseline | ELEC ENG; COMP SCIENT [160 h] | 11,179.2 | 2532200 | CHUDAKOV | 1 | 1 | D | S | EUGENE C | 11-006 | 11-026 | 12-021 | 12-040 | EJ | 13-015 | PR | 14-001 |  |  |  |
| 2532110 | Archiving Run Conditions | 181d | 2014-01-15 | 2014-09-30 | 9-140M FS+66d | 0d |  | 8/5 M-F w/JLAB Holidays ReBaseline | VISTNG USERS [600 h]; SCIENTIST [160 h] | 24,382.8 | 2532110 | CHUDAKOV | 1 | 1 | D | S | EUGENE C | 11-006 | 11-026 | 12-021 | 12-040 | EJ | 13-015 | PR | 14-001 |  | 13-007 |  |
| 2532195 | Active collimator integration EPICS (Acceler grp) | 173d | 2014-01-17 | 2014-09-22 | 9-140M FS+68d | 6d |  | 8/5 M-F w/JLAB Holidays ReBaseline | COMP SCIENT [440 h] | 30,742.8 | 2532195 | CHUDAKOV | 1 | 1 | D | S | EUGENE C | 11-006 | 11-026 | 12-021 | 12-040 | EJ | 13-015 | PR | 14-001 |  | 13-007 |  |
| 2532235 | Scaler Monitoring in EPICS | 179d | 2014-01-17 | 2014-09-30 | 9-140M FS+68d | 0d |  | 8/5 M-F w/JLAB Holidays ReBaseline | SCIENTIST [320 h] | 24,057.6 | 2532235 | CHUDAKOV | 1 | 1 | D | S | EUGENE C | 11-006 | 11-026 | 12-021 | 12-040 | EJ | 13-015 | PR | 14-001 |  |  |  |
| 2532240 | Trigger Monitoring in EPICS | 179d | 2014-01-17 | 2014-09-30 | 9-140M FS+68d | 0d |  | 8/5 M-F w/JLAB Holidays ReBaseline | SCIENTIST [160 h] | 12,028.8 | 2532240 | CHUDAKOV | 1 | 1 | D | S | EUGENE C | 11-006 | 11-026 | 12-021 | 12-040 | EJ | 13-015 | PR | 14-001 |  |  |  |
| 2532150 | FCAL Dark Room Controls | 42d | 2014-02-10 | 2014-04-08 | 9-140M FS+83d | 65d |  | 8/5 M-F w/JLAB Holidays ReBaseline | MECH ENG [160 h] | 11,947.2 | 2532150 | CHUDAKOV | 1 | 1 | D | S | EUGENE C | 11-006 | 11-026 | 12-021 | 12-040 | EJ | 13-015 | PR | 14-001 |  | 13-007 |  |
| 2532085 | Archiving and Retrieval of Histogram Files | 138d | 2014-03-04 | 2014-09-16 | 2532030, 9-140M FS+99d | 10d |  | 8/5 M-F w/JLAB Holidays ReBaseline | SCIENTIST [200 h] | 15,036 | 2532085 | CHUDAKOV | 1 | 1 | D | S | EUGENE C | 11-006 | 11-026 | 12-021 |  | EJ | 13-015 | PR | 14-001 | 12-054 | 13-007 |  |
| 2532090 | Event Display | 122d | 2014-03-05 | 2014-08-25 | 9-140M FS+100d | 25d |  | 8/5 M-F w/JLAB Holidays ReBaseline | CONTRB UNIV LBR [880 h]; SCIENTIST [80 h] | 6,014.4 | 2532090 | CHUDAKOV | 1 | 1 | D | S | EUGENE C | 11-006 | 11-026 | 12-021 |  | EJ | 13-015 | PR | 14-001 |  | 13-007 |  |
| 2532220 | Debug EPICS Controls Sofware | 127d | 2014-03-18 | 2014-09-15 | 2532205a, 2532200, 2531165a, 2532215, 2532190, 2531165, 2532205, 2532185, 2532215a | 11d |  | 8/5 M-F w/JLAB Holidays ReBaseline | VISTNG USERS [200 h]; SCIENTIST [200 h] | 19,154 | 2532220 | CHUDAKOV | 1 | 1 | D | S | EUGENE C | 11-006 | 11-026 | 12-021 | 12-040 | EJ | 13-015 | PR | 14-001 |  |  |  |
| 2532255 | Coherent Peak Alignment Software with Goniometer | 122d | 2014-04-01 | 2014-09-22 | 2532250a, 2532250 | 6d |  | 8/5 M-F w/JLAB Holidays ReBaseline | SCIENTIST [200 h] | 15,036 | 2532255 | CHUDAKOV | 1 | 1 | D | S | EUGENE C | 11-006 | 11-026 | 12-021 | 12-040 | EJ | 13-015 | PR | 14-001 |  |  |  |
| 2532175a | LV Controls (BCAl; ST; FDC) Phase 2 | 127d | 2014-04-02 | 2014-09-30 | 2532175b, 2532175 | 0d |  | 8/5 M-F w/JLAB Holidays ReBaseline | MECH TECH [200 h]; SCIENTIST [160 h] | 21,492.8 | 2532175a | CHUDAKOV | 1 | 1 | D | S | EUGENE C | 11-006 | 11-026 | 12-021 | 12-040 | EJ | 13-015 | PR | 14-001 |  |  |  |
| 2532225 | Debug PLC Controls Sofware | 127d | 2014-04-02 | 2014-09-30 | 2532130, 2532145, 2532150 FS-70d, 2532135, 2532155, 2532140 | 0d |  | 8/5 M-F w/JLAB Holidays ReBaseline | SCIENTIST [40 h]; MECH ENG [200 h] | 17,941.2 | 2532225 | CHUDAKOV | 1 | 1 | D | S | EUGENE C | 11-006 | 11-026 | 12-021 | 12-040 | EJ | 13-015 | PR | 14-001 |  |  |  |
| 2532060 | Debug DAQ software | 113d | 2014-04-22 | 2014-09-30 | 2532040a, 2532070, 2532050a, 2532035, 2532050, 2532040, 2532055, 2532015, 2532035a, 2532070a | 0d |  | 8/5 M-F w/JLAB Holidays ReBaseline | SCIENTIST [320 h] | 24,057.6 | 2532060 | CHUDAKOV | 1 | 1 | D | S | EUGENE C | 11-006 | 11-026 | 12-021F |  | EJ | 13-015 | PR | 14-001 | 12-054F | 13-007F |  |

Notes:
- 2532075: Explanation: IPL from 6 GeV 571130

| ID | WBS | Activity | Type | Duration | Start | Finish | Predecessors | Total float | Free float | Calendar | Resources | Cost | RESP - Responsibility | STRT%COMP for CM EVM | FNSH%COMP for CM EVM | HALL D Related Milestones | CR 07-024 | CAM RESPONSIBLE | CR 11-006 | CR 11-026 | Inter Project Link (IPL) | Advance Purchase Plan > 500K | CR 08-016 | CR 08-036 | 12 GEV MAJOR PROCUREMENT CATAGORY | CR 10-024 | CR 10-042 | CR 11-049 | CR 12-014 | CR 12-047 | CR 08-035 | Duplications | CR 09-014 | CR 12-021 | CR 12-044 | CR 09-012 | CR 12-001 | CR 08-052 | CR 09-045 | CR 12-054 | CR 13-014 | ReBaseline Actuals Adjustment | Original Activity ID Rebaseline | Over Under Fixed | EVMS Reporting Codes | BOE Labor | CR 13-015 | Post Rebaseline | Obligated Prior to Rebaseline | CR 13-007 | CR 14-001 |
| --- | --- | --- | --- | --- | --- | --- | --- | --- | --- | --- | --- | --- | --- | --- | --- | --- | --- | --- | --- | --- | --- | --- | --- | --- | --- | --- | --- | --- | --- | --- | --- | --- | --- | --- | --- | --- | --- | --- | --- | --- | --- | --- | --- | --- | --- | --- | --- | --- | --- | --- | --- |
|  | 3 | **1.5.3.3 OFFLINE COMPUTING** |  |  |  |  |  |  |  |  |  |  |  |  |  |  |  |  |  |  |  |  |  |  |  |  |  |  |  |  |  |  |  |  |  |  |  |  |  |  |  |  |  |  |  |  |  |  |  |  |  |
|  | 4 | **1.5.4 ELECTRONICS** |  |  | 2008-11-03 | 2014-09-30 |  |  |  |  |  |  |  |  |  |  |  |  |  |  |  |  |  |  |  |  |  |  |  |  |  |  |  |  |  |  |  |  |  |  |  |  |  |  |  |  |  |  |  |  |  |
|  | 1 | **1.5.4.1 FADC** |  |  | 2009-10-01 | 2014-09-30 |  |  |  |  |  |  |  |  |  |  |  |  |  |  |  |  |  |  |  |  |  |  |  |  |  |  |  |  |  |  |  |  |  |  |  |  |  |  |  |  |  |  |  |  |  |
| 1541010E |  | FY10 Travel (FADC) |  | 248d | 2009-10-01 | 2010-09-30 | 9-100M | 438d | 0d |  | TRAVEL | 574.67 | CHUDAKOV | 1 | 1 | D | 07-024 | EUGENE C | 11-006 | 11-026 |  |  |  |  |  |  |  |  |  |  |  |  |  |  |  |  |  |  |  |  |  |  |  |  |  |  |  |  |  |  |  |
| 1541029 |  | Vend Fab First Article fADCs for PMTs (FADC) (IPL 5541140M) |  | 68d | 2010-06-07 | 2010-09-10 | 9-100M FS+166d | 326d | 179d |  | PROCUREMENT<$50K 60; PROCUREMENT>$50K 69 | 140,000 | CHUDAKOV | 1 | 1 | D | 07-024 | EUGENE C | 11-006 | 11-026 | IPL | APP | 08-016 | 08-036 | 541B | 10-024 | 10-042 | 11-049 | 12-014 | 12-047F |  |  |  |  |  |  |  |  |  |  |  |  |  |  |  |  |  |  |  |  |  |
| 1541084 |  | First Articles fADCs for DCs (FADC) (IPL 5541170) |  | 120d | 2010-07-02 | 2010-12-29 | 9-100M FS+185d | 467d | 44d |  | PROCUREMENT<$50K 60 NO ESCALATION FY11; PROCUREMENT>$50K 69 NO ESCALATION FY11 | 80,000 | CHUDAKOV | 1 | 1 | D | 07-024 | EUGENE C | 11-006 | 11-026 | IPL | APP |  |  | 541A |  | 10-042 | 11-049 |  |  | 08-035 | DUP | 09-014 | 12-021F | 12-044F |  |  |  |  |  |  |  |  |  |  |  |  |  |  |  |  |
| 1541005 |  | Calibrate ADC gain and linearity (FADC) |  | 25d | 2010-10-01 | 2010-11-04 | 9-110M | 253d | 0d |  | ELEC TECH [880 h]; SCIENTIST [440 h] | 67,746.8 | CHUDAKOV | 1 | 1 | D | 07-024 | EUGENE C | 11-006 | 11-026 |  |  |  |  |  |  |  | 11-049 | 12-014 | 12-047F |  | DUP |  |  |  | 09-012 |  |  |  |  |  |  |  |  |  |  |  |  |  |  |  |
| 1541011E |  | FY11 Travel (FADC) |  | 248d | 2010-10-01 | 2011-09-30 | 1541010E | 438d | 0d |  | TRAVEL | 593 | CHUDAKOV | 1 | 1 | D | 07-024 | EUGENE C | 11-006 | 11-026 |  |  |  |  |  |  |  |  |  |  |  |  |  |  |  |  |  |  |  |  |  |  |  |  |  |  |  |  |  |  |  |
| 1541010 |  | Develop gain correction database for FADC in FPGA (FADC) |  | 25d | 2010-11-05 | 2010-12-13 | 9-110M, 1541005 | 253d | 0d |  | SCIENTIST [480 h] | 32,846.4 | CHUDAKOV | 1 | 1 | D | 07-024 | EUGENE C | 11-006 | 11-026 |  |  |  |  |  |  |  | 11-049 | 12-014 | 12-047F |  | DUP |  |  |  | 09-012 |  |  |  |  |  |  |  |  |  |  |  |  |  |  |  |
| 1541015 |  | Implement PMT Features Extraction Algorithms (FADC) |  | 9d | 2010-12-14 | 2010-12-31 | 9-110M, 1541010 | 253d | 106d |  | SCIENTIST [176 h]; ELEC DES [112 h] | 17,526.08 | CHUDAKOV | 1 | 1 | D | 07-024 | EUGENE C | 11-006 | 11-026 |  |  |  |  |  |  |  | 11-049 | 12-014 | 12-047F |  | DUP |  |  |  | 09-012 |  |  |  |  |  |  |  |  |  |  |  |  |  |  |  |
| 1541085 |  | fADC125 - Procurement Support Pre Production Modules (QTY 3) |  | 69d | 2011-03-07 | 2011-06-10 | 9-110M FS+101d, 1541084 | 423d | 121d |  | ELEC TECH [160 h] | 6,843.2 | CHUDAKOV | 1 | 1 | D | 07-024 | EUGENE C | 11-006 | 11-026 | IPL | APP |  |  | 541A |  | 10-042 | 11-049 |  |  | 08-035 | DUP | 09-014 | 12-021F | 12-044F |  |  |  |  |  |  |  |  |  |  |  |  |  |  |  |  |
| 1541030 |  | fADC250 - Full Single-Crate Acceptance Test (FADC) |  | 68d | 2011-06-06 | 2011-09-09 | 1541015, 1541029, 9-110M FS+165d | 147d | 0d |  | ELEC ENG [160 h]; ELEC TECH [160 h] | 17,784 | CHUDAKOV | 1 | 1 | D | 07-024 | EUGENE C | 11-006 | 11-026 | IPL | APP | 08-016 | 08-036 | 541B | 10-024 | 10-042 | 11-049 | 12-014 | 12-047F |  |  |  |  |  |  |  |  |  |  |  |  |  |  |  |  |  |  |  |  |  |
| 1541040 |  | fADC250 - Production Procurement Support (FADC) FY11 |  | 37d | 2011-08-10 | 2011-09-30 | 1541030 FS-22d | 147d | 0d |  | ELEC ENG [95.48 h] | 6,528.92 | CHUDAKOV | 1 | 1 | D | 07-024 | EUGENE C | 11-006 | 11-026 |  |  |  |  |  |  |  | 11-049 | 12-014 | 12-047F |  |  |  |  |  |  | 12-001 |  |  |  |  |  |  |  |  |  |  |  |  |  |  |
| 1541012E |  | FY12 Travel (FADC) |  | 247d | 2011-10-03 | 2012-09-28 | 1541011E | 438d | 0d |  | TRAVEL | 611.92 | CHUDAKOV | 1 | 1 | D | 07-024 | EUGENE C | 11-006 | 11-026 |  |  |  |  |  |  |  |  |  |  |  |  |  |  |  |  |  |  |  |  |  |  |  |  |  |  |  |  |  |  |  |
| 1541040a |  | fADC250 - Production Procurement Support (FADC) FY12 |  | 25d | 2011-10-03 | 2011-11-04 | 1541040 | 147d | 34d |  | ELEC ENG [64.52 h] | 4,552.53 | CHUDAKOV | 1 | 1 | D | 07-024 | EUGENE C | 11-006 | 11-026 |  |  |  |  |  |  |  | 11-049 | 12-014 | 12-047F |  |  |  |  |  |  | 12-001 |  |  |  |  |  |  |  |  |  |  |  |  |  |  |
| 1541065 |  | Assemble DC Logic/Signal Analyzers (FADC) (in 6 GeV also) |  | 25d | 2011-10-03 | 2011-11-04 | 9-120M | 395d | 0d |  |  |  | CHUDAKOV | 1 | 1 | D | 07-024 | EUGENE C | 11-006 | 11-026 |  |  |  |  |  |  |  | 11-049 |  |  |  | DUP |  | 12-021F |  | 09-012 |  | 08-052 |  |  |  |  |  |  |  |  |  |  |  |  |  |
| 1541125 |  | fADC125 - Procurement Support (FADC) |  | 10d | 2011-10-18 | 2011-10-31 | 9-120M FS+11d | 343d | 171d |  | ELEC TECH [80 h] | 3,530.4 | CHUDAKOV | 1 | 1 | D | 07-024 | EUGENE C | 11-006 | 11-026 | IPL | APP |  |  | 541A |  | 10-042 | 11-049 |  |  | 08-035 | DUP | 09-014 | 12-021F | 12-044F |  |  |  |  |  |  |  |  |  |  |  |  |  |  |  |  |
| 1541112 |  | Test stand for testing/acceptance of FADC125 |  | 119d | 2011-11-01 | 2012-04-27 | 1541100 FS-119d, 9-120M | 302d | 251d |  | ELEC ENG [200 h]; SCIENTIST [200 h] | 28,234 | CHUDAKOV | 1 | 1 | D | 07-024 | EUGENE C | 11-006 | 11-026 |  |  |  |  |  |  |  | 11-049 |  |  |  | DUP |  | 12-021F | 12-044F | 09-012 |  |  | 09-045 |  |  |  |  |  |  |  |  |  |  |  |  |
| 1541070 |  | Implement DC CODA Libraries (FADC) (in 6 GeV also) |  | 25d | 2011-11-07 | 2011-12-13 | 1541065, 9-120M | 395d | 0d |  |  |  | CHUDAKOV | 1 | 1 | D | 07-024 | EUGENE C | 11-006 | 11-026 |  |  |  |  |  |  |  | 11-049 |  |  |  | DUP |  | 12-021F |  | 09-012 |  | 08-052 |  |  |  |  |  |  |  |  |  |  |  |  |  |
| 1541085b |  | fADC125 - Pre Production Modules (QTY 3) |  | 57d | 2011-12-05 | 2012-03-02 | 1541085, 9-120M FS+43d | 302d | 0d |  | PROCUREMENT<$50K 60 | 12,750 | CHUDAKOV | 1 | 1 | D | 07-024 | EUGENE C | 11-006 | 11-026 |  | APP |  |  | 541A |  | 10-042 | 11-049 |  |  | 08-035 | DUP | 09-014 | 12-021 | 12-044F |  |  |  |  |  |  |  |  |  |  |  |  |  |  |  |  |
| 1541075 |  | Implement DC Features Extraction Algorithms (FADC) |  | 25d | 2011-12-14 | 2012-01-26 | 1541070, 9-120M | 395d | 0d |  | SCIENTIST [880 h]; ELEC DES [560 h] | 90,422.4 | CHUDAKOV | 1 | 1 | D | 07-024 | EUGENE C | 11-006 | 11-026 |  |  |  |  |  |  |  | 11-049 |  |  |  | DUP |  | 12-021F |  | 09-012 |  |  |  |  |  |  |  |  |  |  |  |  |  |  |  |
| 1541045 |  | fADC250 - Production (FADC) |  | 231d | 2012-01-04 | 2012-11-30 | 9-120M FS+59d, 1541040a | 113d | 0d |  | PROCUREMENT<$50K 60 NO ESCALATION; PROCUREMENT>$50K 69 NO ESCALATION | 1,446,246.9 | CHUDAKOV | 1 | 1 | D | 07-024 | EUGENE C | 11-006 | 11-026 |  |  |  |  |  |  |  | 11-049 | 12-014 | 12-047F |  |  |  |  |  |  |  |  |  |  |  |  |  |  |  |  |  |  |  |  |  |
| 1541100 |  | fADC125 - Test Pre Production Modules (QTY 3) |  | 76d | 2012-01-11 | 2012-04-27 | 1541085b FS-36d | 302d | 0d |  | ELEC ENG [80 h]; ELEC TECH [200 h] | 14,470.8 | CHUDAKOV | 1 | 1 | D | 07-024 | EUGENE C | 11-006 | 11-026 |  |  |  |  |  |  |  | 11-049 |  |  |  |  | 09-014 | 12-021F | 12-044F |  |  |  |  |  |  |  |  |  |  |  |  |  |  |  |  |
| 1541080 |  | Dry Run of Test DC Procedures (FADC) (in 6 GeV also) |  | 25d | 2012-01-27 | 2012-03-02 | 1541075, 9-120M | 395d |  |  |  |  | CHUDAKOV | 1 | 1 | D | 07-024 | EUGENE C | 11-006 | 11-026 |  |  |  |  |  |  |  | 11-049 |  |  |  | DUP |  | 12-021F |  | 09-012 |  | 08-052 |  |  |  |  |  |  |  |  |  |  |  |  |  |
| 1541130 |  | Vend Fab FADC125 Peg Points #1 and # 2 Board Samples Mezzanine and Main |  | 36d | 2012-07-13 | 2012-08-31 | 9-120M FS+192d, 1541125 | 172d | 0d |  |  |  | CHUDAKOV | 1 | 1 | D | 07-024 | EUGENE C | 11-006 | 11-026 |  | APP |  |  | 541A |  | 10-042 | 11-049 |  |  | 08-035 | DUP | 09-014 | 12-021 | 12-044 |  |  |  |  |  |  |  |  |  |  |  |  |  |  |  |  |
| 1541132 |  | Vend Fab FADC125 Peg Points #3 and # 4 First Article Mezzanine and Main (Qty. 1 Each) |  | 78d | 2012-07-13 | 2012-10-31 | 1541130 FS-36d | 172d | 0d |  | PROCUREMENT<$50K 60 NO ESCALATION | 13,763.77 | CHUDAKOV | 1 | 1 | D | 07-024 | EUGENE C | 11-006 | 11-026 |  | APP |  |  | 541A |  | 10-042 | 11-049 |  |  | 08-035 | DUP | 09-014 | 12-021 | 12-044 |  |  |  |  |  |  |  |  |  |  |  |  |  |  |  |  |
| 1541134 |  | Vend Fab FADC125 Peg Points #5 and # 6 Production Units Mezzanine and Main (Qty. 50 Each) |  | 114d | 2012-07-13 | 2012-12-31 | 1541132 FS-78d | 178d | 0d |  | PROCUREMENT<$50K 60 NO ESCALATION; PROCUREMENT>$50K 69 NO ESCALATION | 155,746.5 | CHUDAKOV | 1 | 1 | D | 07-024 | EUGENE C | 11-006 | 11-026 |  | APP |  |  | 541A |  | 10-042 | 11-049 |  |  | 08-035 | DUP | 09-014 | 12-021 | 12-044 |  |  |  |  |  |  |  |  |  |  |  |  |  |  |  |  |
| 1541136 |  | Vend Fab FADC125 Peg Points #7 and # 8 Production Units Mezzanine and Main (Qty. 50 Each) |  | 114d | 2012-07-13 | 2012-12-31 | 1541134 FS-114d | 178d | 0d |  | PROCUREMENT>$50K 69 NO ESCALATION | 155,746.5 | CHUDAKOV | 1 | 1 | D | 07-024 | EUGENE C | 11-006 | 11-026 |  | APP |  |  | 541A |  | 10-042 | 11-049 |  |  | 08-035 | DUP | 09-014 | 12-021 | 12-044 |  |  |  |  |  |  |  |  |  |  |  |  |  |  |  |  |
| 1541138 |  | Vend Fab FADC125 Peg Points #9 and # 10 Production Units Mezzanine and Main (Qty. 50 Each) |  | 135d | 2012-07-13 | 2013-01-31 | 1541136 FS-114d | 178d | 0d |  | PROCUREMENT>$50K 69 NO ESCALATION | 155,746.5 | CHUDAKOV | 1 | 1 | D | 07-024 | EUGENE C | 11-006 | 11-026 |  | APP |  |  | 541A |  | 10-042 | 11-049 |  |  | 08-035 | DUP | 09-014 | 12-021 | 12-044 |  |  |  |  |  |  |  |  |  |  |  |  |  |  |  |  |
| 1541143 |  | Vend Fab FADC125 Peg Points #11 and # 12 Production Units Mezzanine and Main (Qty. 66 Each) |  | 135d | 2012-07-13 | 2013-01-31 | 1541138 FS-135d | 178d | 127d |  | PROCUREMENT>$50K 69 NO ESCALATION | 205,585.38 | CHUDAKOV | 1 | 1 | D | 07-024 | EUGENE C | 11-006 | 11-026 |  | APP |  |  | 541A |  | 10-042 | 11-049 |  |  | 08-035 | DUP | 09-014 | 12-021 | 12-044 |  |  |  |  |  |  |  |  |  |  |  |  |  |  |  |  |
| 1541057 |  | UMASS - fADC250 - Production Test (FADC) Rediness Review |  | 5d | 2012-09-24 | 2012-09-28 | 1543125, 1543016a, 1541045 FS-48d | 113d | 0d |  | ELEC ENG [8 h]; SCIENTIST [8 h] | 1,129.36 | CHUDAKOV | 1 | 1 | D | 07-024 | EUGENE C | 11-006 | 11-026 |  |  |  |  |  |  |  | 11-049 |  | 12-047 |  |  |  |  |  |  |  |  |  |  |  |  |  |  |  |  |  |  |  |  |  |
| 1541013E |  | FY13 Travel (FADC) |  | 58d | 2012-10-01 | 2012-12-21 | 1541012E | 438d |  |  | TRAVEL | 158.16 | CHUDAKOV | 1 | 1 | D | 07-024 | EUGENE C | 11-006 | 11-026 |  |  |  |  |  |  |  |  |  |  |  |  |  |  |  |  |  |  |  |  |  |  |  |  |  |  |  |  |  |  |  |
| 1541058M |  | UMASS - Begin fADC250 - Production Test (FADC) | milestone | 0d | 2012-10-31 | 2012-10-31 | 1541057 FS+22d | 113d | 0d |  |  |  | CHUDAKOV | 1 | 1 | D | 07-024 | EUGENE C | 11-006 | 11-026 |  |  |  |  |  |  |  | 11-049 |  | 12-047 |  |  |  |  |  |  |  |  |  |  |  |  |  |  |  |  |  |  |  |  |  |
| 1541059 |  | UMASS - fADC250 - Production Test (FADC) |  | 98d | 2012-10-31 | 2013-03-29 | 1541058M | 113d | 0d |  | PROCUREMENT<$50K 60 NO ESCALATION | 43,349.84 | CHUDAKOV | 1 | 1 | D | 07-024 | EUGENE C | 11-006 | 11-026 |  |  |  |  |  |  |  | 11-049 |  | 12-047 |  |  |  |  |  |  |  |  |  |  |  |  |  |  |  |  |  |  |  |  |  |
| 1541060 |  | Assy of fADC PMT as part of Trigger (FADC) |  | 65d | 2012-12-03 | 2013-03-13 | 1541045 | 140d |  |  | ELEC DES [240 h] | 12,508.8 | CHUDAKOV | 1 | 1 | D | 07-024 | EUGENE C | 11-006 | 11-026 |  |  |  |  |  |  |  | 11-049 |  |  |  |  |  |  |  |  |  |  |  |  |  |  |  |  |  |  |  |  |  |  |  |
| 1541145 |  | fADC125 - Test (Qty 217) (FADC) |  | 84d | 2013-05-03 | 2013-08-30 | 1541112, 9-130M FS+144d, 1541132, 1541143 FS-63d | 51d | 0d |  | ELEC TECH [489.87 h]; ELEC ENG [27.6 h] | 24,318.24 | CHUDAKOV | 1 | 1 | D | 07-024 | EUGENE C | 11-006 | 11-026 |  |  |  |  |  |  |  | 11-049 |  |  |  |  | 09-014 | 12-021 | 12-044 |  |  |  |  | 12-054 | 13-014 |  |  |  |  |  |  |  |  |  |  |
| 1541120 |  | fADC125 - Full Single-Crate Acceptance Test (FADC) |  | 41d | 2013-05-21 | 2013-07-18 | 1541145 FS-72d, 9-130M FS+80d | 51d |  |  | ELEC TECH [160 h]; ELEC ENG [160 h] | 18,936 | CHUDAKOV | 1 | 1 | D | 07-024 | EUGENE C | 11-006 | 11-026 |  |  |  |  |  |  |  | 11-049 |  |  |  |  | 09-014 | 12-021 | 12-044 |  |  |  |  | 12-054 |  |  |  |  |  |  |  |  |  |  |  |
| 1541150 |  | Re-Baseline Actuals Adjustment |  | 1d | 2013-08-30 | 2013-08-30 | 9-130M FS+227d | 20d |  |  | PROCUREMENT>$50K 69 NO ESCALATION | -60,191.42 | CHUDAKOV | 1 | 1 |  |  | EUGENE C |  |  |  |  |  |  |  |  |  |  |  |  |  |  |  |  |  |  |  |  |  |  | 13-014 | ADJ |  |  |  |  |  |  |  |  |  |
| 2541000 |  | Vend Fab FADC-125 (Previously Obligated) |  | 210d | 2013-09-03 | 2014-07-10 | 9-130M FS+228d | 57d |  | 8/5 M-F w/JLAB Holidays ReBaseline | PROCUREMENT>$50K 69 NO ESCALATION | 43,318.25 | CHUDAKOV | 1 | 1 | D | 07-024 | EUGENE C | 11-006 | 11-026 |  |  |  |  |  |  |  | 11-049 | 12-014 | 12-047F |  | DUP |  |  |  | 09-012 |  |  |  |  |  |  | 2541015 | y | U | PE | 13-015 | PR | OB |  |  |
| 2541015 |  | Rework of Production FADC Modules (FE) FY13 |  | 20d | 2013-09-03 | 2013-09-30 | 9-130M FS+228d | 57d | 0d | 8/5 M-F w/JLAB Holidays ReBaseline | ELEC ENG [17.78 h]; ELEC TECH [35.55 h] | 2,913.42 | CHUDAKOV | 1 | 1 | D | 07-024 | EUGENE C | 11-006 | 11-026 |  |  |  |  |  |  |  | 11-049 | 12-014 | 12-047F |  | DUP |  |  |  | 09-012 |  |  |  |  |  |  | 2541015 |  | U | PE | 13-015 | PR |  |  |  |
| 2541145 |  | fADC125 - Test (Qty 217) (FADC) FY13 |  | 20d | 2013-09-03 | 2013-09-30 | 9-130M FS+228d | 111d | 0d | 8/5 M-F w/JLAB Holidays ReBaseline | ELEC TECH [10.97 h]; ELEC ENG [1.29 h] | 593.51 | CHUDAKOV | 1 | 1 | D | 07-024 | EUGENE C | 11-006 | 11-026 |  |  |  |  |  |  |  | 11-049 |  |  |  |  | 09-014 | 12-021 | 12-044 |  |  |  |  | 12-054 |  |  | 2541145 |  | U | EJ | 13-015 | PR |  |  |  |
| 2541150 |  | FADC125 Production firmware development FY13 (Hall D EE) |  | 20d | 2013-09-03 | 2013-09-30 | 9-130M FS+228d | 1d | 0d | 8/5 M-F w/JLAB Holidays ReBaseline | ELEC ENG [72.96 h] | 5,312.22 | CHUDAKOV | 1 | 1 | D |  | EUGENE C |  |  |  |  |  |  |  |  |  |  |  |  |  |  |  |  |  |  |  |  |  |  |  |  | 2541150 |  | S | EJ | 13-015 | PR |  | 13-007 |  |
| 2541152 |  | Algorithm Development for DC FADC125 FY13 |  | 20d | 2013-09-03 | 2013-09-30 | 9-130M FS+228d | 0d |  | 8/5 M-F w/JLAB Holidays ReBaseline | SCIENTIST [23.43 h] | 1,707.11 | CHUDAKOV | 1 | 1 | D |  | EUGENE C |  |  |  |  |  |  |  |  |  |  |  |  |  |  |  |  |  |  |  |  |  |  |  |  | 2541152 |  | S | PE | 13-015 | PR |  | 13-007 |  |
| 2541120 |  | fADC125 - Full Single-Crate Acceptance Test (FADC) FY13 |  | 16d | 2013-09-09 | 2013-09-30 | 2541145 FS-58d, 2541145a FS-58d | 111d | 0d | 8/5 M-F w/JLAB Holidays ReBaseline | ELEC TECH [35.07 h]; ELEC ENG [35.07 h] | 4,150.54 | CHUDAKOV | 1 | 1 | D | 07-024 | EUGENE C | 11-006 | 11-026 |  |  |  |  |  |  |  | 11-049 |  |  |  |  | 09-014 | 12-021 | 12-044 |  |  |  |  | 12-054 |  |  | 2541120 |  | U | PE | 13-015 | PR |  |  |  |
| 2541015a |  | Rework of Production FADC Modules (FE) FY14 |  | 190d | 2013-10-01 | 2014-07-10 | 9-130M FS+228d, 2541015 | 57d |  | 8/5 M-F w/JLAB Holidays ReBaseline | ELEC ENG [168.89 h]; ELEC TECH [337.78 h] | 28,560.99 | CHUDAKOV | 1 | 1 | D | 07-024 | EUGENE C | 11-006 | 11-026 |  |  |  |  |  |  |  | 11-049 | 12-014 | 12-047F |  | DUP |  |  |  | 09-012 |  |  |  |  |  |  | 2541015 |  | U | PE | 13-015 | PR |  |  | 14-001 |
| 2541120a |  | fADC125 - Full Single-Crate Acceptance Test (FADC) FY14 |  | 57d | 2013-10-01 | 2013-12-20 | 2541120, 2541145a FS-58d, 2541145 FS-58d | 111d | 0d | 8/5 M-F w/JLAB Holidays ReBaseline | ELEC TECH [124.93 h]; ELEC ENG [124.93 h] | 15,256.45 | CHUDAKOV | 1 | 1 | D | 07-024 | EUGENE C | 11-006 | 11-026 |  |  |  |  |  |  |  | 11-049 |  |  |  |  | 09-014 | 12-021 | 12-044 |  |  |  |  | 12-054 |  |  | 2541120 |  | U | PE | 13-015 | PR |  |  | 14-001 |
| 2541145a |  | fADC125 - Test (Qty 217) (FADC) FY14 |  | 42d | 2013-10-01 | 2013-11-27 | 9-130M FS+228d, 2541145 | 111d | 0d | 8/5 M-F w/JLAB Holidays ReBaseline | ELEC TECH [23.03 h]; ELEC ENG [2.71 h] | 1,285.76 | CHUDAKOV | 1 | 1 | D | 07-024 | EUGENE C | 11-006 | 11-026 |  |  |  |  |  |  |  | 11-049 |  |  |  |  | 09-014 | 12-021 | 12-044 |  |  |  |  | 12-054 |  |  | 2541145 |  | U | EJ | 13-015 | PR |  |  | 14-001 |
| 2541150a |  | FADC125 Production firmware development FY14 (Hall D EE) |  | 57d | 2013-10-01 | 2013-12-20 | 2541150, 9-130M FS+228d | 1d |  | 8/5 M-F w/JLAB Holidays ReBaseline | ELEC ENG [207.04 h] | 15,554.92 | CHUDAKOV | 1 | 1 | D |  | EUGENE C |  |  |  |  |  |  |  |  |  |  |  |  |  |  |  |  |  |  |  |  |  |  |  |  | 2541150 |  | S | EJ | 13-015 | PR |  | 13-007 | 14-001 |
| 2541152a |  | Algorithm Development for DC FADC125 FY14 |  | 219d | 2013-10-01 | 2014-08-20 | 9-130M FS+228d, 2541152 | 0d |  | 8/5 M-F w/JLAB Holidays ReBaseline | SCIENTIST [256.57 h] | 19,288.93 | CHUDAKOV | 1 | 1 | D |  | EUGENE C |  |  |  |  |  |  |  |  |  |  |  |  |  |  |  |  |  |  |  |  |  |  |  |  | 2541152 |  | S | PE | 13-015 | PR |  | 13-007 | 14-001 |
| 2541155 |  | FADC EE Hardware/software support in FY14 (Hall D EE) |  | 205d | 2013-12-02 | 2014-09-30 | 2541150 FS-16d, 2541150a FS-16d, 9-140M FS+42d | 0d |  | 8/5 M-F w/JLAB Holidays ReBaseline | ELEC ENG [800 h] | 60,104 | CHUDAKOV | 1 | 1 | D |  | EUGENE C |  |  |  |  |  |  |  |  |  |  |  |  |  |  |  |  |  |  |  |  |  |  |  |  | 2541155 |  | E | PE | 13-015 | PR |  | 13-007 | 14-001 |
| 2541154 |  | Code Deployment and Full Readout Tests FADC125 |  | 124d | 2014-04-07 | 2014-09-30 | 2541152a FS-96d, 2541152 FS-96d | 0d |  | 8/5 M-F w/JLAB Holidays ReBaseline | SCIENTIST [240 h] | 18,043.2 | CHUDAKOV | 1 | 1 | D |  | EUGENE C |  |  |  |  |  |  |  |  |  |  |  |  |  |  |  |  |  |  |  |  |  |  |  |  | 2541154 |  | S | EJ | 13-015 | PR |  | 13-007 | 14-001 |

Notes:
- 1541029: Explanation: IPL from 6 GeV 5541140M
- 1541084: Explanation: IPL from 6 GeV 5541170
- 1541085: Explanation: IPL from 6 GeV 5541170
- 1541030: Explanation: IPL from 6 GeV 5541140M
- 1541125: Explanation: IPL from 6 GeV 5541170

| ID | WBS | Activity | Type | Duration | Start | Finish | Predecessors | Total float | Free float | Calendar | Resources | Cost | RESP - Responsibility | STRT%COMP for CM EVM | FNSH%COMP for CM EVM | HALL D Related Milestones | CR 07-024 | CR 08-016 | CAM RESPONSIBLE | CR 08-038 | CR 09-002 | Duplications | CR 09-012 | CR 11-006 | CR 11-026 | CR 11-049 | CR 12-021 | CR 12-054 | CR 08-052 | CR 09-045 | CR 10-024 | CR 12-047 | CR 12-053 | CR 13-014 | ReBaseline Actuals Adjustment | Original Activity ID Rebaseline | EVMS Reporting Codes | BOE Labor | CR 13-015 | Post Rebaseline | CR 13-007 | CR 14-001 |
| --- | --- | --- | --- | --- | --- | --- | --- | --- | --- | --- | --- | --- | --- | --- | --- | --- | --- | --- | --- | --- | --- | --- | --- | --- | --- | --- | --- | --- | --- | --- | --- | --- | --- | --- | --- | --- | --- | --- | --- | --- | --- | --- |
|  | 2 | **1.5.4.2 TDC** |  |  | 2008-11-03 | 2014-09-30 |  |  |  |  |  |  |  |  |  |  |  |  |  |  |  |  |  |  |  |  |  |  |  |  |  |  |  |  |  |  |  |  |  |  |  |  |
| 1542025 |  | Phase 1 Proc TDCs (TDC) |  | 247d | 2008-11-03 | 2009-10-30 | 9-090M FS+23d | 370d | 285d |  | PROCUREMENT<$50K 60 NO ESCALATION FY10; PROCUREMENT>$50K 69 NO ESCALATION FY10 | 199,281.6 | CHUDAKOV | 1 | 1 | D | 07-024 | 08-016 | EUGENE C | 08-038 | 09-002 | DUP | 09-012 | 11-006 | 11-026 | 11-049 | 12-021F | 12-054F |  |  |  |  |  |  |  |  |  |  |  |  |  |  |
| 1542005 |  | Assemble Logic/Signal Analyzers (TDC) (in 6 GeV also) |  | 43.5d | 2010-10-01 | 2010-12-03 | 9-110M, 1234180M | 85d | 0d |  |  |  | CHUDAKOV | 1 | 1 | D | 07-024 |  | EUGENE C |  |  | DUP | 09-012 | 11-006 | 11-026 | 11-049 | 12-021F | 12-054F | 08-052 |  |  |  |  |  |  |  |  |  |  |  |  |  |
| 1542011E |  | FY11 Travel (TDC) |  | 248d | 2010-10-01 | 2011-09-30 | 9-110M | 190d | 0d |  | TRAVEL | 857.18 | CHUDAKOV | 1 | 1 | D | 07-024 |  | EUGENE C |  |  |  |  |  | 11-026 |  |  |  |  |  |  |  |  |  |  |  |  |  |  |  |  |  |
| 1542010 |  | Measure cross talk for CFD & TDC (TDC) |  | 15.5d | 2010-12-03 | 2010-12-31 | 9-110M, 1542005 | 85d | 0d |  | ELEC TECH [313.56 h]; SCIENTIST [171.04 h] | 25,115.23 | CHUDAKOV | 1 | 1 | D | 07-024 |  | EUGENE C |  |  | DUP | 09-012 | 11-006 | 11-026 | 11-049 | 12-021F | 12-054F |  |  |  |  |  |  |  |  |  |  |  |  |  |  |
| 1542025a |  | F1TDC - First Article Procurement Support (TDC) |  | 92d | 2011-01-04 | 2011-05-13 | 1234180M, 1542010, 1542025, 9-110M FS+59d | 85d | 0d |  | ELEC TECH [240 h]; ELEC ENG [160 h] | 21,205.6 | CHUDAKOV | 1 | 1 | D | 07-024 | 08-016 | EUGENE C | 08-038 | 09-002 | DUP |  | 11-006 | 11-026 | 11-049 | 12-021F | 12-054F |  | 09-045 | 10-024 |  |  |  |  |  |  |  |  |  |  |  |
| 1542026 |  | F1TDC - Parts (TDC) |  | 121d | 2011-01-18 | 2011-07-08 | 1542025a FS-83d | 85d | 0d |  | PROCUREMENT<$50K 60 | 40,000 | CHUDAKOV | 1 | 1 | D |  |  | EUGENE C |  |  | DUP |  | 11-006 | 11-026 | 11-049 | 12-021F | 12-054F |  |  |  |  |  |  |  |  |  |  |  |  |  |  |
| 1542015 |  | Dry Run of Test Procedures TDC |  | 100d | 2011-03-10 | 2011-07-29 | 1542010 FS+45d | 305d | 44d |  | ELEC ENG [400 h] | 27,352 | CHUDAKOV | 1 | 1 | D | 07-024 |  | EUGENE C |  |  | DUP |  | 11-006 | 11-026 |  | 12-021F |  |  |  |  |  |  |  |  |  |  |  |  |  |  |  |
| 1542027 |  | F1TDC - First Article Fab V2 (QTY 2) (TDC) |  | 14d | 2011-08-29 | 2011-09-16 | 1542026 FS+35d | 85d | 0d |  | PROCUREMENT<$50K 60 | 2,000 | CHUDAKOV | 1 | 1 | D |  |  | EUGENE C |  |  | DUP |  | 11-006 | 11-026 | 11-049 | 12-021F | 12-054F |  |  |  |  |  |  |  |  |  |  |  |  |  |  |
| 1542030 |  | F1TDC - First Article Assembly V2 (QTY 2) (TDC) |  | 15d | 2011-09-19 | 2011-10-07 | 1542027 | 85d | 0d |  | PROCUREMENT<$50K 60 NO ESCALATION FY12 | 2,500 | CHUDAKOV | 1 | 1 | D | 07-024 |  | EUGENE C |  |  | DUP | 09-012 | 11-006 | 11-026 | 11-049 | 12-021F | 12-054F |  | 09-045 |  |  |  |  |  |  |  |  |  |  |  |  |
| 1542012E |  | FY12 Travel (TDC) |  | 247d | 2011-10-03 | 2012-09-28 | 1542011E | 190d | 0d |  | TRAVEL | 884.52 | CHUDAKOV | 1 | 1 | D | 07-024 |  | EUGENE C |  |  |  |  |  | 11-026 |  |  |  |  |  |  |  |  |  |  |  |  |  |  |  |  |  |
| 1542036 |  | Test stand for testing/acceptance of F1TDC |  | 67d | 2011-10-03 | 2012-01-13 | 1542010, 9-120M, 1542015 | 261d | 203d |  | ELEC ENG [200 h]; SCIENTIST [200 h] | 28,234 | CHUDAKOV | 1 | 1 | D | 07-024 |  | EUGENE C |  |  | DUP | 09-012 | 11-006 | 11-026 |  | 12-021F |  |  | 09-045 |  |  |  |  |  |  |  |  |  |  |  |  |
| 1542031 |  | F1TDC - First Article Fab V3 (QTY 2) (TDC) |  | 10d | 2011-10-31 | 2011-11-11 | 1542030 FS+15d | 85d | 0d |  | PROCUREMENT<$50K 60 | 2,063.8 | CHUDAKOV | 1 | 1 | D |  |  | EUGENE C |  |  | DUP |  | 11-006 | 11-026 | 11-049 | 12-021F | 12-054F |  |  |  |  |  |  |  |  |  |  |  |  |  |  |
| 1542031a |  | F1TDC - First Article Assembly V3 (QTY 2) (TDC) |  | 41d | 2011-11-21 | 2012-01-27 | 1542031 FS+5d | 85d | 54d |  | PROCUREMENT<$50K 60 | 2,579.75 | CHUDAKOV | 1 | 1 | D | 07-024 |  | EUGENE C |  |  | DUP | 09-012 | 11-006 | 11-026 | 11-049 | 12-021F | 12-054F |  | 09-045 |  |  |  |  |  |  |  |  |  |  |  |  |
| 1542030a |  | F1TDC - First Article Test V2 (QTY 2) (TDC) |  | 78d | 2012-03-26 | 2012-07-13 | 9-120M FS+115d, 1542030 | 21d | 0d |  | ELEC TECH [136 h]; ELEC ENG [96 h] | 12,775.44 | CHUDAKOV | 1 | 1 | D | 07-024 |  | EUGENE C |  |  | DUP | 09-012 | 11-006 | 11-026 | 11-049 | 12-021 | 12-054F |  | 09-045 |  |  |  |  |  |  |  |  |  |  |  |  |
| 1542031b |  | F1TDC - First ArticleTest V3 (QTY 2) (TDC) |  | 53d | 2012-04-16 | 2012-06-29 | 9-120M FS+130d, 1542031a | 31d | 10d |  | ELEC ENG [96 h]; ELEC TECH [136 h] | 12,775.44 | CHUDAKOV | 1 | 1 | D | 07-024 |  | EUGENE C |  |  | DUP | 09-012 | 11-006 | 11-026 | 11-049 | 12-021 | 12-054F |  | 09-045 |  |  |  |  |  |  |  |  |  |  |  |  |
| 1542032 |  | F1TDC - First Article Fab (QTY 18) (TDC) |  | 20d | 2012-07-16 | 2012-08-10 | 9-120M FS+35d, 1542030a, 1542031b, 1542031a, 1542030 | 21d | 0d |  | PROCUREMENT<$50K 60 | 8,667.96 | CHUDAKOV | 1 | 1 | D |  |  | EUGENE C |  |  | DUP |  | 11-006 | 11-026 | 11-049 | 12-021 | 12-054F |  |  |  |  |  |  |  |  |  |  |  |  |  |  |
| 1542035 |  | F1TDC - First Article Assembly (QTY 18) (TDC) |  | 57d | 2012-08-13 | 2012-10-31 | 1542032 | 21d | 0d |  | PROCUREMENT<$50K 60 NO ESCALATION FY13 | 11,970.04 | CHUDAKOV | 1 | 1 | D | 07-024 |  | EUGENE C |  |  | DUP | 09-012 | 11-006 | 11-026 | 11-049 | 12-021 | 12-054 |  | 09-045 |  |  |  |  |  |  |  |  |  |  |  |  |
| 1542013E |  | FY13 Travel (TDC) |  | 58d | 2012-10-01 | 2012-12-21 | 1542012E | 190d |  |  | TRAVEL | 226.99 | CHUDAKOV | 1 | 1 | D | 07-024 |  | EUGENE C |  |  |  |  |  | 11-026 |  |  |  |  |  |  |  |  |  |  |  |  |  |  |  |  |  |
| 1542035a |  | F1TDC - First ArticleTest V2 (QTY 18) (TDC) |  | 150d | 2012-11-01 | 2013-06-13 | 1542035 | 21d | 0d |  | ELEC ENG [56 h]; ELEC TECH [272 h] | 16,464.24 | CHUDAKOV | 1 | 1 | D | 07-024 |  | EUGENE C |  |  | DUP | 09-012 | 11-006 | 11-026 | 11-049 | 12-021 | 12-054 |  | 09-045 |  | 12-047F | 12-053 |  |  |  |  |  |  |  |  |  |
| 1542037 |  | F1TDC - Full Single-Crate Acceptance Test (TDC) |  | 58d | 2012-11-01 | 2013-02-01 | 1542036, 1542035 | 58d | 0d |  | ELEC ENG [160 h]; ELEC TECH [160 h] | 18,936 | CHUDAKOV | 1 | 1 | D |  |  | EUGENE C |  |  | DUP |  | 11-006 | 11-026 | 11-049 | 12-021 | 12-054 |  |  |  |  | 12-053 |  |  |  |  |  |  |  |  |  |
| 1542040 |  | F1TDC - Production Procurement Prep (TDC) |  | 62d | 2012-12-17 | 2013-03-22 | 1542037 FS-28d | 58d | 0d |  | ELEC TECH [160 h] | 7,286.4 | CHUDAKOV | 1 | 1 | D | 07-024 |  | EUGENE C |  |  | DUP | 09-012 | 11-006 | 11-026 | 11-049 | 12-021 | 12-054F |  | 09-045 |  |  |  |  |  |  |  |  |  |  |  |  |
| 1542042 |  | F1TDC - Production (TDC) |  | 85d | 2013-05-02 | 2013-08-30 | 1542040 FS+28d | 58d | 37d |  | PROCUREMENT<$50K 60 NO ESCALATION FY14; PROCUREMENT>$50K 69 NO ESCALATION FY14 |  | CHUDAKOV | 1 | 1 | D |  |  | EUGENE C |  |  | DUP |  | 11-006 | 11-026 | 11-049 | 12-021 | 12-054 |  |  |  |  |  | 13-014 |  |  |  |  |  |  |  |  |
| 1542045 |  | UMASS - F1TDC - Production Test (TDC) Readiness Review |  | 5d | 2013-06-07 | 2013-06-13 | 1542042 FS-97d, 1542035a FS-5d | 21d | 0d |  | ELEC ENG [8 h]; SCIENTIST [8 h] | 1,165.36 | CHUDAKOV | 1 | 1 | D | 07-024 |  | EUGENE C |  |  |  | 09-012 | 11-006 | 11-026 | 11-049 | 12-021 | 12-054 |  | 09-045 |  | 12-047 |  |  |  |  |  |  |  |  |  |  |
| 1542050M |  | UMASS - Begin fADC250 - Production Test (FADC) | milestone | 0d | 2013-06-14 | 2013-06-14 | 1542045 | 21d | 0d |  |  |  | CHUDAKOV | 1 | 1 | D | 07-024 |  | EUGENE C |  |  |  |  | 11-006 | 11-026 | 11-049 |  | 12-054 |  |  |  | 12-047 |  |  |  |  |  |  |  |  |  |  |
| 1542055 |  | UMASS - fADC250 - Production Test (FADC) |  | 54d | 2013-06-14 | 2013-08-29 | 1542050M | 21d |  |  | PROCUREMENT<$50K 60 NO ESCALATION |  | CHUDAKOV | 1 | 1 | D | 07-024 |  | EUGENE C |  |  |  |  | 11-006 | 11-026 | 11-049 |  | 12-054 |  |  |  | 12-047 |  | 13-014 |  |  |  |  |  |  |  |  |
| 1542060 |  | Re-Baseline Actuals Adjustment |  | 1d | 2013-08-30 | 2013-08-30 | 9-130M FS+227d | 20d |  |  | PROCUREMENT>$50K 69 NO ESCALATION | 468,084.23 | CHUDAKOV | 1 | 1 |  |  |  | EUGENE C |  |  |  |  |  |  |  |  |  |  |  |  |  |  | 13-014 | ADJ |  |  |  |  |  |  |  |
| 2542037 |  | F1TDC - Full Single-Crate Acceptance Test (TDC) |  | 14d | 2013-09-03 | 2013-09-20 | 9-130M FS+228d | 253d |  | 8/5 M-F w/JLAB Holidays ReBaseline | ELEC ENG [128 h]; ELEC TECH [128 h] | 15,148.8 | CHUDAKOV | 1 | 1 | D |  |  | EUGENE C |  |  | DUP |  | 11-006 | 11-026 | 11-049 | 12-021 | 12-054 |  |  |  |  | 12-053 |  |  | 2542037 | U | PE | 13-015 | PR |  |  |
| 2542070 |  | F1TDC develop firmware FY13 |  | 20d | 2013-09-03 | 2013-09-30 | 9-130M FS+228d | 0d |  | 8/5 M-F w/JLAB Holidays ReBaseline | ELEC ENG [55.31 h] | 4,027.12 | CHUDAKOV | 1 | 1 | D | 07-024 |  | EUGENE C |  |  |  |  | 11-006 | 11-026 | 11-049 |  | 12-054 |  |  |  | 12-047 |  |  |  | 2542070 | S | EJ | 13-015 | PR | 13-007 |  |
| 2542070a |  | F1TDC develop firmware FY14 |  | 61d | 2013-10-01 | 2014-01-07 | 2542070, 9-130M FS+228d | 0d |  | 8/5 M-F w/JLAB Holidays ReBaseline | ELEC ENG [168.69 h] | 12,673.68 | CHUDAKOV | 1 | 1 | D | 07-024 |  | EUGENE C |  |  |  |  | 11-006 | 11-026 | 11-049 |  | 12-054 |  |  |  | 12-047 |  |  |  | 2542070 | S | EJ | 13-015 | PR | 13-007 | 14-001 |
| 2542085 |  | Rework of Production F1TDC modules |  | 134d | 2013-10-10 | 2014-04-30 | 9-140M FS+7d | 106d |  | 8/5 M-F w/JLAB Holidays ReBaseline | ELEC TECH [400 h] | 18,796 | CHUDAKOV | 1 | 1 | D | 07-024 |  | EUGENE C |  |  |  |  | 11-006 | 11-026 | 11-049 |  | 12-054 |  |  |  | 12-047 |  |  |  | 2542085 | U | EJ | 13-015 | PR | 13-007 | 14-001 |
| 2542090 |  | F1TDC EE Hardware/Software Support FY14 |  | 186d | 2014-01-08 | 2014-09-30 | 2542070a, 2542070 | 0d |  | 8/5 M-F w/JLAB Holidays ReBaseline | ELEC ENG [360 h] | 27,046.8 | CHUDAKOV | 1 | 1 | D | 07-024 |  | EUGENE C |  |  |  |  | 11-006 | 11-026 | 11-049 |  | 12-054 |  |  |  | 12-047 |  |  |  | 2542090 | E | PE | 13-015 | PR | 13-007 | 14-001 |
| 2542075 |  | FPGA Coding, Hardware & Firmware Integration Tests F1TDC |  | 44d | 2014-01-29 | 2014-03-31 | 2542070 FS+14d, 2542070a FS+14d | 84d | 0d | 8/5 M-F w/JLAB Holidays ReBaseline | ELEC ENG [240 h] | 18,031.2 | CHUDAKOV | 1 | 1 | D | 07-024 |  | EUGENE C |  |  |  |  | 11-006 | 11-026 | 11-049 |  | 12-054 |  |  |  | 12-047 |  |  |  | 2542075 | S | EJ | 13-015 | PR | 13-007 | 14-001 |
| 2542080 |  | Code Deployment and Full Readout Tests F1TDC |  | 39d | 2014-04-08 | 2014-06-02 | 2542075 FS+5d | 84d |  | 8/5 M-F w/JLAB Holidays ReBaseline | SCIENTIST [160 h] | 12,028.8 | CHUDAKOV | 1 | 1 | D | 07-024 |  | EUGENE C |  |  |  |  | 11-006 | 11-026 | 11-049 |  | 12-054 |  |  |  | 12-047 |  |  |  | 2542080 | S | EJ | 13-015 | PR | 13-007 | 14-001 |

Notes:
- 1542025a: Explanation: IPL From 6 GeV BIA / 5542200M
- 1542026: Explanation: IPL From 6 GeV BIA / 5542200M
- 1542027: Explanation: IPL From 6 GeV BIA / 5542200M
- 1542031: Explanation: IPL From 6 GeV BIA / 5542200M
- 1542032: Explanation: IPL From 6 GeV BIA / 5542200M
- 1542037: Explanation: IPL From 6 GeV BIA / 5542200M
- 1542042: Explanation: IPL From 6 GeV BIA / 5542200M
- 2542037: Explanation: IPL From 6 GeV BIA / 5542200M

| ID | WBS | Activity | Duration | Start | Finish | Predecessors | Total float | Free float | Calendar | Resources | Cost | RESP - Responsibility | STRT%COMP for CM EVM | FNSH%COMP for CM EVM | HALL D Related Milestones | CR 07-024 | CAM RESPONSIBLE | CR 11-006 | CR 11-026 | CR 12-053 | Duplications | CR 09-012 | CR 12-021 | CR 08-052 | CR 07-027 | CR 11-049 | CR 12-047 | CR 12-001 | Inter Project Link (IPL) | CR 10-024 | CR 12-055 | CR 12-054 | CR 13-014 | ReBaseline Actuals Adjustment | Original Activity ID Rebaseline | Over Under Fixed | EVMS Reporting Codes | BOE Procurement | CR 13-015 | Post Rebaseline | Obligated Prior to Rebaseline | BOE Labor | BOE Expenses | CR 14-001 |
| --- | --- | --- | --- | --- | --- | --- | --- | --- | --- | --- | --- | --- | --- | --- | --- | --- | --- | --- | --- | --- | --- | --- | --- | --- | --- | --- | --- | --- | --- | --- | --- | --- | --- | --- | --- | --- | --- | --- | --- | --- | --- | --- | --- | --- |
|  | 3 | **1.5.4.3 TRIGGER** |  | 2009-10-01 | 2014-09-30 |  |  |  |  |  |  |  |  |  |  |  |  |  |  |  |  |  |  |  |  |  |  |  |  |  |  |  |  |  |  |  |  |  |  |  |  |  |  |  |
| 1543010E |  | FY10 Travel (TRIGR) | 248d | 2009-10-01 | 2010-09-30 | 9-100M | 438d | 0d |  | TRAVEL | 1,149.33 | CHUDAKOV | 1 | 1 | D | 07-024 | EUGENE C | 11-006 | 11-026 | 12-053F |  |  |  |  |  |  |  |  |  |  |  |  |  |  |  |  |  |  |  |  |  |  |  |  |
| 1543005 |  | Assemble Logic/Signal Analyzers for Energy Sum Tests (Trigger) | 20d | 2010-10-01 | 2010-10-28 | 9-110M, 1234180M | 606d | 0d |  | CONTRB UNIV LBR [440 h] |  | CHUDAKOV | 1 | 1 | D |  | EUGENE C | 11-006 | 11-026 |  | DUP | 09-012 | 12-021F |  |  |  |  |  |  |  |  |  |  |  |  |  |  |  |  |  |  |  |  |  |
| 1543011E |  | FY11 Travel (TRIGR) | 248d | 2010-10-01 | 2011-09-30 | 1543010E | 438d | 0d |  | TRAVEL | 1,185.99 | CHUDAKOV | 1 | 1 | D | 07-024 | EUGENE C | 11-006 | 11-026 | 12-053F |  |  |  |  |  |  |  |  |  |  |  |  |  |  |  |  |  |  |  |  |  |  |  |  |
| 1543010 |  | Implement CODA Libraries for Energy Sum (Trigger) (in 6 GeV also) | 20d | 2010-10-29 | 2010-11-29 | 1543005 | 606d | 0d |  |  |  | CHUDAKOV | 1 | 1 | D | 07-024 | EUGENE C | 11-006 | 11-026 |  | DUP | 09-012 | 12-021F | 08-052 |  |  |  |  |  |  |  |  |  |  |  |  |  |  |  |  |  |  |  |  |
| 1543015 |  | Implement Features Extraction Algorithms | 20d | 2010-11-30 | 2011-01-04 | 1543010 | 606d | 478d |  | CONTRB UNIV LBR [440 h] |  | CHUDAKOV | 1 | 1 | D |  | EUGENE C | 11-006 | 11-026 |  | DUP | 09-012 | 12-021F |  |  |  |  |  |  |  |  |  |  |  |  |  |  |  |  |  |  |  |  |  |
| 1543120 |  | Prepare test stand for testing/acceptance of FADC250 | 93d | 2011-01-04 | 2011-05-16 | 9-110M FS+59d | 451d | 0d |  | ELEC ENG [63.6 h] | 4,348.97 | CHUDAKOV | 1 | 1 | D | 07-024 | EUGENE C | 11-006 | 11-026 |  |  |  |  |  | 07-027 | 11-049 | 12-047F |  |  |  |  |  |  |  |  |  |  |  |  |  |  |  |  |  |
| 1543125 |  | Procument equipment for testing FADC250 | 93d | 2011-01-04 | 2011-05-16 | 1543120 FS-93d | 451d | 338d |  | PROCUREMENT<$50K 60 | 7,000 | CHUDAKOV | 1 | 1 | D | 07-024 | EUGENE C | 11-006 | 11-026 |  |  |  |  |  |  | 11-049 | 12-047F |  |  |  |  |  |  |  |  |  |  |  |  |  |  |  |  |  |
| 1543140 |  | Develop trigger algorithms FY11 | 189d | 2011-01-04 | 2011-09-30 | 9-110M FS+59d | 209d | 0d |  | SCIENTIST [428.5 h] | 29,322.26 | CHUDAKOV | 1 | 1 | D | 07-024 | EUGENE C | 11-006 | 11-026 |  |  |  | 12-021F |  | 07-027 |  |  | 12-001 |  |  |  |  |  |  |  |  |  |  |  |  |  |  |  |  |
| 1543105 |  | Full crate performance testing | 129d | 2011-03-01 | 2011-08-30 | 9-110M FS+97d | 452d | 432d |  | ELEC ENG [126 h] | 8,615.88 | CHUDAKOV | 1 | 1 | D |  | EUGENE C | 11-006 | 11-026 |  |  |  | 12-021F |  |  |  |  |  |  |  |  |  |  |  |  |  |  |  |  |  |  |  |  |  |
| 1543016 |  | Programing FADC250 FPGAs FY11 | 128d | 2011-04-01 | 2011-09-30 | 9-110M FS+120d | 235d | 0d |  | ELEC ENG [330.32 h] | 22,587.28 | CHUDAKOV | 1 | 1 | D |  | EUGENE C | 11-006 | 11-026 |  | DUP | 09-012 |  |  |  | 11-049 | 12-047F | 12-001 |  |  |  |  |  |  |  |  |  |  |  |  |  |  |  |  |
| 1543110 |  | Testing of multi-crate board performance FY11 | 107d | 2011-05-02 | 2011-09-30 | 9-110M FS+141d | 388d | 0d |  | ELEC ENG [430.87 h]; SCIENTIST [114.9 h] | 37,325.5 | CHUDAKOV | 1 | 1 | D |  | EUGENE C | 11-006 | 11-026 |  |  |  | 12-021F |  |  |  |  | 12-001 |  |  |  |  |  |  |  |  |  |  |  |  |  |  |  |  |
| 1543023 |  | Preparing procument of CTP boards | 48d | 2011-05-03 | 2011-07-11 | 9-110M FS+142d | 228d | 208d |  | ELEC ENG [160 h] | 10,940.8 | CHUDAKOV | 1 | 1 | D | 07-024 | EUGENE C | 11-006 | 11-026 |  |  |  | 12-021F |  | 07-027 | 11-049 |  |  | IPL | 10-024 |  |  |  |  |  |  |  |  |  |  |  |  |  |  |
| 1543050 |  | Preparing procument of SD boards | 15d | 2011-05-09 | 2011-05-27 | 9-110M FS+146d | 219d | 108d |  | ELEC ENG [160 h] | 10,940.8 | CHUDAKOV | 1 | 1 | D |  | EUGENE C | 11-006 | 11-026 |  | DUP | 09-012 | 12-021F |  |  | 11-049 |  |  |  |  |  |  |  |  |  |  |  |  |  |  |  |  |  |  |
| 1543065 |  | Preparing procument of SSP boards FY11 | 83d | 2011-06-06 | 2011-09-30 | 9-110M FS+165d | 266d | 0d |  | ELEC ENG [150.91 h] | 10,319.23 | CHUDAKOV | 1 | 1 | D |  | EUGENE C | 11-006 | 11-026 |  | DUP | 09-012 | 12-021F | 08-052 |  | 11-049 |  | 12-001 |  |  |  |  |  |  |  |  |  |  |  |  |  |  |  |  |
| 1543035 |  | Preparing procument TI-D boards | 45d | 2011-07-06 | 2011-09-07 | 9-110M FS+186d | 126d | 15d |  | ELEC ENG [160 h] | 10,940.8 | CHUDAKOV | 1 | 1 | D | 07-024 | EUGENE C | 11-006 | 11-026 |  |  |  | 12-021F |  | 07-027 | 11-049 |  |  |  |  |  |  |  |  |  |  |  |  |  |  |  |  |  |  |
| 1543080 |  | Preparing procument of GTP boards FY11 | 10d | 2011-09-19 | 2011-09-30 | 9-110M FS+238d | 108d | 0d |  | ELEC ENG [69.57 h] | 4,757.2 | CHUDAKOV | 1 | 1 | D | 07-024 | EUGENE C | 11-006 | 11-026 |  |  |  | 12-021F |  | 07-027 | 11-049 |  | 12-001 |  |  |  |  |  |  |  |  |  |  |  |  |  |  |  |  |
| 1543012E |  | FY12 Travel (TRIGR) | 247d | 2011-10-03 | 2012-09-28 | 1543011E | 438d | 0d |  | TRAVEL | 1,223.82 | CHUDAKOV | 1 | 1 | D | 07-024 | EUGENE C | 11-006 | 11-026 | 12-053 |  |  |  |  |  |  |  |  |  |  |  |  |  |  |  |  |  |  |  |  |  |  |  |  |
| 1543016a |  | Programing FADC250 FPGAs FY12 | 120d | 2011-10-03 | 2012-03-30 | 1543016 | 235d | 122d |  | ELEC ENG [309.68 h] | 21,851.02 | CHUDAKOV | 1 | 1 | D |  | EUGENE C | 11-006 | 11-026 |  | DUP | 09-012 |  |  |  | 11-049 | 12-047F | 12-001 |  |  |  |  |  |  |  |  |  |  |  |  |  |  |  |  |
| 1543040 |  | Procument of TI-D boards (FE grp) Part A | 270d | 2011-10-03 | 2012-10-31 | 1543035 FS+2d, 9-120M | 111d | 0d |  | PROCUREMENT<$50K 60 NO ESCALATION FY13; PROCUREMENT>$50K 69 NO ESCALATION FY13 | 137,837.7 | CHUDAKOV | 1 | 1 | D | 07-024 | EUGENE C | 11-006 | 11-026 |  |  |  | 12-021 |  | 07-027 | 11-049 |  |  |  |  | 12-055 |  |  |  |  |  |  |  |  |  |  |  |  |  |
| 1543040a |  | Procument of TI-D boards (FE grp) Part B | 270d | 2011-10-03 | 2012-10-31 | 1543035 FS+2d, 9-120M | 111d | 0d |  | PROCUREMENT>$50K 69 NO ESCALATION FY13 | 51,000 | CHUDAKOV | 1 | 1 | D | 07-024 | EUGENE C | 11-006 | 11-026 |  |  |  | 12-021 |  | 07-027 | 11-049 |  |  |  |  | 12-055 |  |  |  |  |  |  |  |  |  |  |  |  |  |
| 1543065a |  | Preparing procument of SSP boards FY12 (FE grp) | 5d | 2011-10-03 | 2011-10-07 | 1543065 | 266d | 246d |  | ELEC ENG [9.09 h] | 641.39 | CHUDAKOV | 1 | 1 | D |  | EUGENE C | 11-006 | 11-026 |  | DUP | 09-012 | 12-021F | 08-052 |  | 11-049 |  | 12-001 |  |  |  |  |  |  |  |  |  |  |  |  |  |  |  |  |
| 1543080a |  | Preparing procument of GTP boards FY12 | 13d | 2011-10-03 | 2011-10-19 | 1543080 | 108d | 65d |  | ELEC ENG [90.43 h] | 6,380.74 | CHUDAKOV | 1 | 1 | D | 07-024 | EUGENE C | 11-006 | 11-026 |  |  |  | 12-021F |  | 07-027 | 11-049 |  | 12-001 |  |  |  |  |  |  |  |  |  |  |  |  |  |  |  |  |
| 1543095 |  | Preparing procument of Fiber Optics Cable/Patch Pannel | 20d | 2011-10-03 | 2011-10-28 | 9-120M | 370d | 0d |  | ELEC ENG [120 h] | 8,467.2 | CHUDAKOV | 1 | 1 | D | 07-024 | EUGENE C | 11-006 | 11-026 |  |  |  | 12-021F |  | 07-027 |  |  |  |  |  |  |  |  |  |  |  |  |  |  |  |  |  |  |  |
| 1543110a |  | Testing of multi-crate board performance FY12 | 42d | 2011-10-03 | 2011-12-01 | 1543110 | 388d | 368d |  | ELEC ENG [169.13 h]; SCIENTIST [45.1 h] | 15,118.32 | CHUDAKOV | 1 | 1 | D |  | EUGENE C | 11-006 | 11-026 |  |  |  | 12-021F |  |  |  |  | 12-001 |  |  |  |  |  |  |  |  |  |  |  |  |  |  |  |  |
| 1543135 |  | Develop FADC250 features extraction algorithms (readout) (Hall D grp) | 120d | 2011-10-03 | 2012-03-30 | 9-120M | 147d | 127d |  | SCIENTIST [320 h] | 22,595.2 | CHUDAKOV | 1 | 1 | D | 07-024 | EUGENE C | 11-006 | 11-026 |  |  |  | 12-021F |  | 07-027 |  |  |  |  |  |  |  |  |  |  |  |  |  |  |  |  |  |  |  |
| 1543140a |  | Develop trigger algorithms FY12 (Hall D grp) | 58d | 2011-10-03 | 2011-12-30 | 1543140 | 209d | 189d |  | SCIENTIST [131.5 h] | 9,285.22 | CHUDAKOV | 1 | 1 | D | 07-024 | EUGENE C | 11-006 | 11-026 |  |  |  | 12-021F |  | 07-027 |  |  | 12-001 |  |  |  |  |  |  |  |  |  |  |  |  |  |  |  |  |
| 1543100 |  | Procument Fiber Optics Cable/Patch Pannel (FE grp) | 40d | 2011-10-31 | 2012-01-04 | 1543095 | 370d | 350d |  | PROCUREMENT<$50K 60 | 20,638 | CHUDAKOV | 1 | 1 | D |  | EUGENE C | 11-006 | 11-026 |  |  |  | 12-021 |  | 07-027 |  |  |  | IPL |  |  |  |  |  |  |  |  |  |  |  |  |  |  |  |
| 1543055 |  | Procument of SD boards (FE grp) Part A | 249d | 2011-11-01 | 2012-10-31 | 1543050, 9-120M FS+21d | 111d | 0d |  | PROCUREMENT<$50K 60 NO ESCALATION FY13; PROCUREMENT>$50K 69 NO ESCALATION FY13 | 111,147 | CHUDAKOV | 1 | 1 | D |  | EUGENE C | 11-006 | 11-026 |  | DUP | 09-012 | 12-021 | 08-052 |  | 11-049 |  |  |  |  | 12-055 |  |  |  |  |  |  |  |  |  |  |  |  |  |
| 1543055a |  | Procument of SD boards (FE grp) Part B | 249d | 2011-11-01 | 2012-10-31 | 9-120M FS+21d, 1543050 | 111d | 0d |  | PROCUREMENT>$50K 69 NO ESCALATION FY13 | 23,000 | CHUDAKOV | 1 | 1 | D |  | EUGENE C | 11-006 | 11-026 |  | DUP | 09-012 | 12-021 | 08-052 |  | 11-049 |  |  |  |  | 12-055 |  |  |  |  |  |  |  |  |  |  |  |  |  |
| 1543085 |  | Procument of GTP boards (FE grp) Part A | 332d | 2012-02-01 | 2013-05-30 | 1543080a, 9-120M FS+78d | 43d | 0d |  | PROCUREMENT<$50K 60 NO ESCALATION FY13 | 3,319 | CHUDAKOV | 1 | 1 | D | 07-024 | EUGENE C | 11-006 | 11-026 |  |  |  | 12-021 |  |  | 11-049 |  |  |  |  | 12-055 |  |  |  |  |  |  |  |  |  |  |  |  |  |
| 1543085a |  | Procument of GTP boards (FE grp) Part B | 332d | 2012-02-01 | 2013-05-30 | 9-120M FS+78d, 1543080a | 43d | 0d |  | PROCUREMENT<$50K 60 NO ESCALATION FY13 | 7,000 | CHUDAKOV | 1 | 1 | D | 07-024 | EUGENE C | 11-006 | 11-026 |  |  |  | 12-021 |  |  | 11-049 |  |  |  |  | 12-055 |  |  |  |  |  |  |  |  |  |  |  |  |  |
| 1543141 |  | Procure Equipment for Algorithm Test Stand ( Hall D grp ) Part A | 87d | 2012-05-01 | 2012-08-31 | 9-120M FS+141d | 39d | 19d |  | PROCUREMENT<$50K 60 | 8,100 | CHUDAKOV | 1 | 1 | D |  | EUGENE C |  |  |  |  |  | 12-021 |  |  |  |  |  |  |  | 12-055 |  |  |  |  |  |  |  |  |  |  |  |  |  |
| 1543141a |  | Procure Equipment for Algorithm Test Stand ( Hall D grp ) Part B | 87d | 2012-05-01 | 2012-08-31 | 9-120M FS+141d | 39d | 19d |  | PROCUREMENT<$50K 60 | 10,000 | CHUDAKOV | 1 | 1 | D |  | EUGENE C |  |  |  |  |  | 12-021 |  |  |  |  |  |  |  | 12-055 |  |  |  |  |  |  |  |  |  |  |  |  |  |
| 1543017 |  | Preparing procument of TS board | 17d | 2012-05-07 | 2012-05-30 | 9-120M FS+145d | 256d | 128d |  | ELEC ENG [160 h] | 11,289.6 | CHUDAKOV | 1 | 1 | D | 07-024 | EUGENE C | 11-006 | 11-026 |  | DUP | 09-012 | 12-021F |  |  |  |  |  |  |  |  |  |  |  |  |  |  |  |  |  |  |  |  |  |
| 1543130 |  | Implement playback mode | 84d | 2012-06-01 | 2012-09-28 | 9-120M FS+163d | 20d | 0d |  | ELEC ENG [240 h]; SCIENTIST [120 h] | 25,407.6 | CHUDAKOV | 1 | 1 | D | 07-024 | EUGENE C | 11-006 | 11-026 |  |  |  | 12-021F |  | 07-027 |  |  |  |  |  |  |  |  |  |  |  |  |  |  |  |  |  |  |  |
| 1543045 |  | Acceptance test of TI boards (FE grp) FY12 | 76d | 2012-06-14 | 2012-09-28 | 1543040 FS-99d, 1543040a FS-99d | 111d | 0d |  | ELEC ENG [164.32 h] | 11,594.42 | CHUDAKOV | 1 | 1 | D | 07-024 | EUGENE C | 11-006 | 11-026 | 12-053 |  |  | 12-021 |  | 07-027 | 11-049 |  |  |  |  |  |  |  |  |  |  |  |  |  |  |  |  |  |  |
| 1543060 |  | Acceptance test of SD boards (FE grp) FY12 | 76d | 2012-06-14 | 2012-09-28 | 1543055a FS-99d, 1543055 FS-99d | 111d | 0d |  | ELEC ENG [164.32 h] | 11,594.42 | CHUDAKOV | 1 | 1 | D |  | EUGENE C | 11-006 | 11-026 | 12-053 | DUP | 09-012 | 12-021 |  |  | 11-049 |  |  |  |  |  |  |  |  |  |  |  |  |  |  |  |  |  |  |
| 1543013E |  | FY13 Travel (TRIGR) | 58d | 2012-10-01 | 2012-12-21 | 1543012E | 438d |  |  | TRAVEL | 316.32 | CHUDAKOV | 1 | 1 | D | 07-024 | EUGENE C | 11-006 | 11-026 | 12-053 |  |  |  |  |  |  |  |  |  |  |  |  |  |  |  |  |  |  |  |  |  |  |  |  |
| 1543060a |  | Acceptance test of SD boards (FE grp) FY13 | 72d | 2012-10-01 | 2013-01-18 | 1543055a FS-99d, 1543055 FS-99d, 1543060 | 111d | 91d |  | ELEC ENG [155.68 h] | 11,335.06 | CHUDAKOV | 1 | 1 | D |  | EUGENE C | 11-006 | 11-026 | 12-053 | DUP | 09-012 | 12-021 |  |  | 11-049 |  |  |  |  |  |  |  |  |  |  |  |  |  |  |  |  |  |  |
| 1543142 |  | Prepare Test Stand for Algorithm Testing, Test Algorithms ( Hall D grp ) | 228d | 2012-10-01 | 2013-08-30 | 1543141a, 9-130M, 9-120M FS+228d, 1543141 | 20d |  |  | SCIENTIST [683.15 h] | 49,774.31 | CHUDAKOV | 1 | 1 | D |  | EUGENE C |  |  | 12-053 |  |  | 12-021 |  |  |  |  |  |  |  |  | 12-054 | 13-014 |  |  |  |  |  |  |  |  |  |  |  |
| 1543025 |  | Procument of CTP boards (FE grp) | 118d | 2012-10-03 | 2013-03-29 | 1543023 FS+99d, 9-130M FS+2d | 20d | 0d |  | PROCUREMENT<$50K 60; PROCUREMENT>$50K 69 | 133,102.2 | CHUDAKOV | 1 | 1 | D | 07-024 | EUGENE C | 11-006 | 11-026 |  |  |  | 12-021 |  | 07-027 | 11-049 | 12-047F |  | IPL | 10-024 |  |  |  |  |  |  |  |  |  |  |  |  |  |  |
| 1543070 |  | Procument of SSP boards (FE grp) | 116d | 2012-10-05 | 2013-03-29 | 1543065a, 9-130M FS+4d | 20d | 0d |  | PROCUREMENT>$50K 69; PROCUREMENT<$50K 60 | 53,240.88 | CHUDAKOV | 1 | 1 | D |  | EUGENE C | 11-006 | 11-026 |  |  |  | 12-021 |  | 07-027 | 11-049 |  |  |  |  |  |  |  |  |  |  |  |  |  |  |  |  |  |  |
| 1543020 |  | Procument of TS board (FE grp) | 121d | 2012-12-03 | 2013-05-31 | 1543015, 9-130M FS+43d, 1543017 | 128d | 0d |  | PROCUREMENT<$50K 60 | 10,648.18 | CHUDAKOV | 1 | 1 | D | 07-024 | EUGENE C | 11-006 | 11-026 |  | DUP | 09-012 | 12-021 |  |  |  | 12-047F |  |  |  |  |  |  |  |  |  |  |  |  |  |  |  |  |  |
| 1543115 |  | Performance testing of global trigger system | 65d | 2013-05-31 | 2013-08-30 | 1543060a, 1543100, 182443005, 1543060, 1543110a, 182443015, 1543105, 182443000 FS-150d, 9-120M FS+65d, 182443010 | 20d |  |  | ELEC ENG [277.33 h]; SCIENTIST [138.67 h] | 30,295.89 | CHUDAKOV | 1 | 1 | D |  | EUGENE C | 11-006 | 11-026 |  |  |  | 12-021 |  |  | 11-049 |  |  |  |  |  |  | 13-014 |  |  |  |  |  |  |  |  |  |  |  |
| 1543150 |  | Re-Baseline Actuals Adjustment | 1d | 2013-08-30 | 2013-08-30 | 9-130M FS+227d | 20d |  |  | PROCUREMENT>$50K 69 NO ESCALATION | 227,586.42 | CHUDAKOV | 1 | 1 |  |  | EUGENE C |  |  |  |  |  |  |  |  |  |  |  |  |  |  |  | 13-014 | ADJ |  |  |  |  |  |  |  |  |  |  |
| 2543025 |  | Procument of CTP boards (FE grp) (Previously Obligated) | 20d | 2013-09-03 | 2013-09-30 | 9-130M FS+228d | 148d | 0d | 8/5 M-F w/JLAB Holidays ReBaseline | PROCUREMENT<$50K 60; PROCUREMENT>$50K 69 | 18,009.16 | CHUDAKOV | 1 | 1 | D | 07-024 | EUGENE C | 11-006 | 11-026 |  |  |  | 12-021 |  | 07-027 | 11-049 | 12-047F |  | IPL | 10-024 |  |  |  |  | 2543025 | y | D | OB | 13-015 | PR | OB |  |  |  |
| 2543030 |  | Procument of CTP boards (FE grp) | 20d | 2013-09-03 | 2013-09-30 | 9-130M FS+228d | 148d | 0d | 8/5 M-F w/JLAB Holidays ReBaseline | PROCUREMENT<$50K 60; PROCUREMENT>$50K 69 | 9,682 | CHUDAKOV | 1 | 1 | D | 07-024 | EUGENE C | 11-006 | 11-026 |  |  |  | 12-021 |  | 07-027 | 11-049 | 12-047F |  | IPL | 10-024 |  |  |  |  | 2543025 |  | D | OB | 13-015 | PR |  |  |  |  |
| 2543144 |  | Study Algorithms with Test Stand (Hall D grp) FY13 | 20d | 2013-09-03 | 2013-09-30 | 9-130M FS+228d | 64d | 0d | 8/5 M-F w/JLAB Holidays ReBaseline | SCIENTIST [15.76 h] | 1,148.27 | CHUDAKOV | 1 | 1 | D |  | EUGENE C |  |  |  |  |  | 12-021 |  |  |  |  |  |  |  |  | 12-054 |  |  | 2543144 |  | S |  | 13-015 | PR |  | PE |  |  |
| 2543150 |  | Develop Level-1 Monitor (Hall D grp) FY13 | 20d | 2013-09-03 | 2013-09-30 | 9-130M FS+228d | 251d | 0d | 8/5 M-F w/JLAB Holidays ReBaseline | SCIENTIST [39.56 h]; ELEC ENG [8.79 h] | 3,522.35 | CHUDAKOV | 1 | 1 | D |  | EUGENE C |  |  |  |  |  | 12-021 |  |  |  |  |  |  |  |  | 12-054 |  |  | 2543150 |  | S |  | 13-015 | PR |  | PE |  |  |
| 2543160 |  | Trigger Board Initialization (Hall D grp) FY13 | 20d | 2013-09-03 | 2013-09-30 | 9-130M FS+228d | 7d | 0d | 8/5 M-F w/JLAB Holidays ReBaseline | SCIENTIST [46.77 h] | 3,407.66 | CHUDAKOV | 1 | 1 | D |  | EUGENE C |  |  |  |  |  | 12-021 |  |  |  |  |  |  |  |  | 12-054 |  |  | 2543160 |  | U |  | 13-015 | PR |  | EJ |  |  |
| 2543165 |  | Level-1 Verification and Debugging (Hall D grp) FY13 | 20d | 2013-09-03 | 2013-09-30 | 9-130M FS+228d | 62d | 0d | 8/5 M-F w/JLAB Holidays ReBaseline | SCIENTIST [23.42 h]; ELEC ENG [3.9 h] | 1,990.34 | CHUDAKOV | 1 | 1 | D |  | EUGENE C |  |  |  |  |  | 12-021 |  |  |  |  |  |  |  |  | 12-054 |  |  | 2543165 |  | S |  | 13-015 | PR |  | PE |  |  |
| 2543185 |  | Procument Structural Components for Trigger Modules (FE Grp) | 17d | 2013-09-03 | 2013-09-25 | 9-130M FS+228d | 250d |  | 8/5 M-F w/JLAB Holidays ReBaseline | PROCUREMENT<$50K 60 | 1,448.62 | CHUDAKOV | 1 | 1 | D |  | EUGENE C |  |  |  |  |  | 12-021 |  |  |  |  |  |  |  |  | 12-054 |  |  | 2543185 | y | D |  | 13-015 | PR | OB |  | PE |  |
| 2543115 |  | Performance testing of global trigger system (FE grp) | 44d | 2013-10-01 | 2013-12-03 | 2543025 FS-20d, 2543030 FS-20d, 282443010 FS-100d, 2543100 FS-57d, 282443010a FS-100d | 128d | 0d | 8/5 M-F w/JLAB Holidays ReBaseline | ELEC ENG [360 h]; SCIENTIST [26.8 h] | 29,061.62 | CHUDAKOV | 1 | 1 | D |  | EUGENE C | 11-006 | 11-026 |  |  |  | 12-021 |  |  | 11-049 |  |  |  |  |  |  |  |  | 2543115 |  | S |  | 13-015 | PR |  | EJ |  | 14-001 |
| 2543144a |  | Study Algorithms with Test Stand (Hall D grp) FY14 | 183d | 2013-10-01 | 2014-06-30 | 2543144, 9-130M FS+228d | 64d |  | 8/5 M-F w/JLAB Holidays ReBaseline | SCIENTIST [144.24 h] | 10,843.96 | CHUDAKOV | 1 | 1 | D |  | EUGENE C |  |  |  |  |  | 12-021 |  |  |  |  |  |  |  |  | 12-054 |  |  | 2543144 |  | S |  | 13-015 | PR |  | PE |  | 14-001 |
| 2543150a |  | Develop Level-1 Monitor (Hall D grp) FY14 | 162d | 2013-10-01 | 2014-05-30 | 9-130M FS+228d, 2543150 | 251d | 0d | 8/5 M-F w/JLAB Holidays ReBaseline | SCIENTIST [320.44 h]; ELEC ENG [71.21 h] | 29,440.69 | CHUDAKOV | 1 | 1 | D |  | EUGENE C |  |  |  |  |  | 12-021 |  |  |  |  |  |  |  |  | 12-054 |  |  | 2543150 |  | S |  | 13-015 | PR |  | PE |  | 14-001 |
| 2543160a |  | Trigger Board Initialization (Hall D grp) FY14 | 240d | 2013-10-01 | 2014-09-19 | 9-130M FS+228d, 2543160 | 7d |  | 8/5 M-F w/JLAB Holidays ReBaseline | SCIENTIST [561.23 h] | 42,193.27 | CHUDAKOV | 1 | 1 | D |  | EUGENE C |  |  |  |  |  | 12-021 |  |  |  |  |  |  |  |  | 12-054 |  |  | 2543160 |  | U |  | 13-015 | PR |  | EJ |  | 14-001 |
| 2543165a |  | Level-1 Verification and Debugging (Hall D grp) FY14 | 185d | 2013-10-01 | 2014-07-02 | 9-130M FS+228d, 2543165 | 62d |  | 8/5 M-F w/JLAB Holidays ReBaseline | SCIENTIST [216.58 h]; ELEC ENG [36.1 h] | 18,994.68 | CHUDAKOV | 1 | 1 | D |  | EUGENE C |  |  |  |  |  | 12-021 |  |  |  |  |  |  |  |  | 12-054 |  |  | 2543165 |  | S |  | 13-015 | PR |  | PE |  | 14-001 |
| 2543170 |  | Level-1 Trigger Testbed Electronics (Hall D grp) | 69d | 2013-10-01 | 2014-01-17 | 9-140M | 4d | 3d | 8/5 M-F w/JLAB Holidays ReBaseline | PROCUREMENT<$50K 60 | 19,864.08 | CHUDAKOV | 1 | 1 | D |  | EUGENE C |  |  |  |  |  | 12-021 |  |  |  |  |  |  |  |  | 12-054 |  |  | 2543170 |  | S | VQ | 13-015 | PR |  |  |  | 14-001 |
| 2543100 |  | Procument Fiber Optics Cable/Patch Pannel (FE grp) | 34d | 2013-11-01 | 2013-12-20 | 9-140M FS+23d | 128d | 0d | 8/5 M-F w/JLAB Holidays ReBaseline | PROCUREMENT<$50K 60 | 36,116.5 | CHUDAKOV | 1 | 1 | D |  | EUGENE C | 11-006 | 11-026 |  |  |  | 12-021 |  | 07-027 |  |  |  | IPL |  |  |  |  |  | 2543100 |  | D | EV | 13-015 | PR |  |  |  | 14-001 |
| 2543143 |  | Trigger Algorithms Performance Testing in the Hall (Hall D grp) | 184d | 2014-01-09 | 2014-09-29 | 2543170 FS-10d, 9-140M FS+62d | 1d |  | 8/5 M-F w/JLAB Holidays ReBaseline | SCIENTIST [360 h] | 27,064.8 | CHUDAKOV | 1 | 1 | D |  | EUGENE C |  |  |  |  |  | 12-021 |  |  |  |  |  |  |  |  | 12-054 |  |  | 2543143 |  | S |  | 13-015 | PR |  | PE |  | 14-001 |
| 2543155 |  | Install Level-1 Monitor (Hall D grp) | 85d | 2014-06-02 | 2014-09-30 | 2543150, 2543150a | 251d | 19d | 8/5 M-F w/JLAB Holidays ReBaseline | SCIENTIST [200 h] | 15,036 | CHUDAKOV | 1 | 1 | D |  | EUGENE C |  |  |  |  |  | 12-021 |  |  |  |  |  |  |  |  | 12-054 |  |  | 2543155 |  | S |  | 13-015 | PR |  | PE |  | 14-001 |

Notes:
- 1543023: Explanation: IPL from 6 GeV 5543500M
- 1543100: Explanation: IPL from 6 GeV 5543500M
- 1543025: Explanation: IPL from 6 GeV 5543500M
- 2543025: Explanation: IPL from 6 GeV 5543500M
- 2543030: Explanation: IPL from 6 GeV 5543500M
- 2543144: Steps: Assemble test setup; Prepair analysing software; Program electronics boards; Implement Play Back Mode; Algorithm Performance Studies
- 2543150: Steps: Assemble test setup; Prepair analysing software; Program electronics boards; Implement Play Back Mode; Algorithm Performance Studies
- 2543160: Steps: Assemble test setup; Prepair analysing software; Program electronics boards; Implement Play Back Mode; Algorithm Performance Studies
- 2543165: Steps: Assemble test setup; Prepair analysing software; Program electronics boards; Implement Play Back Mode; Algorithm Performance Studies
- 2543185: Steps: Assemble test setup; Prepair analysing software; Program electronics boards; Implement Play Back Mode; Algorithm Performance Studies
- 2543144a: Steps: Assemble test setup; Prepair analysing software; Program electronics boards; Implement Play Back Mode; Algorithm Performance Studies
- 2543150a: Steps: Assemble test setup; Prepair analysing software; Program electronics boards; Implement Play Back Mode; Algorithm Performance Studies
- 2543160a: Steps: Assemble test setup; Prepair analysing software; Program electronics boards; Implement Play Back Mode; Algorithm Performance Studies
- 2543165a: Steps: Assemble test setup; Prepair analysing software; Program electronics boards; Implement Play Back Mode; Algorithm Performance Studies
- 2543170: Steps: Assemble test setup; Prepair analysing software; Program electronics boards; Implement Play Back Mode; Algorithm Performance Studies
- 2543100: Explanation: IPL from 6 GeV 5543500M
- 2543143: Steps: Assemble test setup; Prepair analysing software; Program electronics boards; Implement Play Back Mode; Algorithm Performance Studies
- 2543155: Steps: Assemble test setup; Prepair analysing software; Program electronics boards; Implement Play Back Mode; Algorithm Performance Studies

| ID | WBS | Activity | Duration | Start | Finish | Predecessors | Total float | Free float | Resources | Cost | RESP - Responsibility | STRT%COMP for CM EVM | FNSH%COMP for CM EVM | HALL D Related Milestones | Advance Purchase Plan > 500K | CAM RESPONSIBLE | CR 08-035 | 12 GEV MAJOR PROCUREMENT CATAGORY | CR 10-053 | CR 10-077 | CR 11-006 | CR 11-026 | CR 12-021 | Profile change | CR 12-054 | CR 12-001 | CR 08-038 | CR 09-012 | CR 13-014 | ReBaseline Actuals Adjustment | CR 07-024 | CR 07-027 | CR 08-058 | CR 11-029 | Duplications | CR 08-036 | CR 10-024 | CR 11-002 | Inter Project Link (IPL) | CR 09-014 | CR 10-042 | CR 12-016 | CR 10-054 | CR 09-045 | CR 12-053 |
| --- | --- | --- | --- | --- | --- | --- | --- | --- | --- | --- | --- | --- | --- | --- | --- | --- | --- | --- | --- | --- | --- | --- | --- | --- | --- | --- | --- | --- | --- | --- | --- | --- | --- | --- | --- | --- | --- | --- | --- | --- | --- | --- | --- | --- | --- |
|  | 4 | **1.5.4.4 CRATES/RACKS** |  | 2010-09-30 | 2013-08-30 |  |  |  |  |  |  |  |  |  |  |  |  |  |  |  |  |  |  |  |  |  |  |  |  |  |  |  |  |  |  |  |  |  |  |  |  |  |  |  |  |
| 1544005 |  | Vend Fab Crate DAQ Type Phase 1 (CRATES/RACKS) Peg Point #1 VXS Prototype | 59d | 2010-09-30 | 2010-12-30 | 9-110M FS-1d, 1234180M | 445d | 0d | PROCUREMENT>$50K 69 NO ESCALATION FY11; PROCUREMENT<$50K 60 NO ESCALATION FY11 | 15,116 | CHUDAKOV | 1 | 1 | D | APP | EUGENE C | 08-035 | 544B | 10-053 | 10-077 | 11-006 | 11-026 | 12-021F |  |  |  |  |  |  |  |  |  |  |  |  |  |  |  |  |  |  |  |  |  |  |
| 1544005a |  | Vend Fab Crate DAQ Type Phase 1 (CRATES/RACKS) Peg Point #2 VME64X Qty 1 | 98d | 2010-09-30 | 2011-02-28 | 1544005 FS-59d | 445d | 0d | PROCUREMENT<$50K 60 NO ESCALATION FY11; PROCUREMENT>$50K 69 NO ESCALATION FY11 | 7,232 | CHUDAKOV | 1 | 1 | D | APP | EUGENE C | 08-035 | 544B | 10-053 | 10-077 | 11-006 | 11-026 | 12-021F |  |  |  |  |  |  |  |  |  |  |  |  |  |  |  |  |  |  |  |  |  |  |
| 1544005b |  | Vend Fab Crate DAQ Type Phase 1 (CRATES/RACKS) Peg Point #3 VME64X Qty 6 | 98d | 2010-09-30 | 2011-02-28 | 1544005a FS-98d | 445d | 0d | PROCUREMENT<$50K 60 NO ESCALATION FY11; PROCUREMENT>$50K 69 NO ESCALATION FY11 | 43,392 | CHUDAKOV | 1 | 1 | D | APP | EUGENE C | 08-035 | 544B | 10-053 | 10-077 | 11-006 | 11-026 | 12-021F |  |  |  |  |  |  |  |  |  |  |  |  |  |  |  |  |  |  |  |  |  |  |
| 1544005c |  | Vend Fab Crate DAQ Type Phase 1 (CRATES/RACKS) Peg Point #4 VXS Qty 3 | 121d | 2010-09-30 | 2011-03-31 | 1544005b FS-98d | 445d | 0d | PROCUREMENT>$50K 69 NO ESCALATION FY11; PROCUREMENT<$50K 60 NO ESCALATION FY11 | 32,604 | CHUDAKOV | 1 | 1 | D | APP | EUGENE C | 08-035 | 544B | 10-053 | 10-077 | 11-006 | 11-026 | 12-021F |  |  |  |  |  |  |  |  |  |  |  |  |  |  |  |  |  |  |  |  |  |  |
| 1544005d |  | Vend Fab Crate DAQ Type Phase 1 (CRATES/RACKS) Peg Point #5 VXS Qty 8 | 121d | 2010-09-30 | 2011-03-31 | 1544005c FS-121d | 445d | 128d | PROCUREMENT<$50K 60 NO ESCALATION FY11; PROCUREMENT>$50K 69 NO ESCALATION FY11 | 86,944 | CHUDAKOV | 1 | 1 | D | APP | EUGENE C | 08-035 | 544B | 10-053 | 10-077 | 11-006 | 11-026 | 12-021F |  |  |  |  |  |  |  |  |  |  |  |  |  |  |  |  |  |  |  |  |  |  |
| 1544050 |  | Racks - First Article Procurement Support (CRATES/RACKS) | 35d | 2011-07-11 | 2011-08-26 | 1234180M, 9-110M FS+189d | 270d | 0d | ELEC ENG [40 h]; ELEC TECH [160 h] | 9,578.4 | CHUDAKOV | 1 | 1 | D | APP | EUGENE C |  | 544A |  |  | 11-006 | 11-026 | 12-021F | C | 12-054F |  |  |  |  |  |  |  |  |  |  |  |  |  |  |  |  |  |  |  |  |
| 1544055 |  | Racks - First Article Parts (QTY 2) (CRATES/RACKS) | 20d | 2011-07-25 | 2011-08-19 | 1544050 FS-25d | 270d | 0d | PROCUREMENT<$50K 60 | 2,400 | CHUDAKOV | 1 | 1 | D | APP | EUGENE C |  | 544A |  |  | 11-006 | 11-026 | 12-021F | C | 12-054F |  |  |  |  |  |  |  |  |  |  |  |  |  |  |  |  |  |  |  |  |
| 1544060 |  | Racks - Cabling Development (CRATES/RACKS) FY11 | 24d | 2011-08-29 | 2011-09-30 | 1544055 FS+5d | 270d | 0d | ELEC TECH [74.81 h]; ELEC ENG [49.87 h] | 6,609.73 | CHUDAKOV | 1 | 1 | D | APP | EUGENE C |  | 544A |  |  | 11-006 | 11-026 | 12-021F | C | 12-054F | 12-001 |  |  |  |  |  |  |  |  |  |  |  |  |  |  |  |  |  |  |  |
| 1544010 |  | Vend Fab Crate DAQ Type Phase 2 (CRATES/RACKS) VME64X | 130d | 2011-10-03 | 2012-04-13 | 9-120M, 1544005d, 1234180M | 317d | 53d | PROCUREMENT>$50K 69 NO ESCALATION | 13,914 | CHUDAKOV | 1 | 1 | D | APP | EUGENE C |  | 544A |  | 10-077 | 11-006 | 11-026 |  |  |  |  | 08-038 |  |  |  |  |  |  |  |  |  |  |  |  |  |  |  |  |  |  |
| 1544060a |  | Racks - Cabling Development (CRATES/RACKS) FY12 | 53d | 2011-10-03 | 2011-12-16 | 1544060 | 270d | 0d | ELEC TECH [165.19 h]; ELEC ENG [110.13 h] | 15,060.6 | CHUDAKOV | 1 | 1 | D | APP | EUGENE C |  | 544A |  |  | 11-006 | 11-026 | 12-021F | C | 12-054F | 12-001 |  |  |  |  |  |  |  |  |  |  |  |  |  |  |  |  |  |  |  |
| 1544030 |  | Proc TDC Auxiliaries (CRATES/RACKS) | 1d | 2011-12-02 | 2011-12-02 | 1234180M, 1544005d, 9-120M FS+42d | 415d | 0d |  |  | CHUDAKOV | 1 | 1 | D | APP | EUGENE C |  | 544A |  |  | 11-006 | 11-026 |  | C |  |  | 08-038 | 09-012 |  |  |  |  |  |  |  |  |  |  |  |  |  |  |  |  |  |
| 1544035 |  | Assemble TDC Crates (CRATES/RACKS) | 11d | 2011-12-05 | 2011-12-19 | 1544030 | 415d | 0d | ELEC TECH [80 h] | 3,530.4 | CHUDAKOV | 1 | 1 | D |  | EUGENE C |  |  |  |  | 11-006 | 11-026 |  |  |  |  |  |  |  |  |  |  |  |  |  |  |  |  |  |  |  |  |  |  |  |
| 1544065 |  | Racks - Production Procurement Support (CRATES/RACKS) | 23d | 2011-12-19 | 2012-01-27 | 1544060a | 270d | 24d | ELEC TECH [160 h]; ELEC ENG [40 h] | 9,883.2 | CHUDAKOV | 1 | 1 | D | APP | EUGENE C |  | 544A |  |  | 11-006 | 11-026 | 12-021F | C | 12-054F |  |  |  |  |  |  |  |  |  |  |  |  |  |  |  |  |  |  |  |  |
| 1544040 |  | Test TDC Crates (CRATES/RACKS) | 11d | 2011-12-20 | 2012-01-11 | 1544035 | 415d | 281d | ELEC TECH [160 h] | 7,060.8 | CHUDAKOV | 1 | 1 | D |  | EUGENE C |  |  |  |  | 11-006 | 11-026 |  |  |  |  |  |  |  |  |  |  |  |  |  |  |  |  |  |  |  |  |  |  |  |
| 1544006 |  | Vend Fab Crate DAQ Type Phase 2 (CRATES/RACKS) VXS | 123d | 2012-01-05 | 2012-06-29 | 1544005d, 9-120M FS+60d | 264d | 0d | PROCUREMENT<$50K 60 NO ESCALATION; PROCUREMENT>$50K 69 NO ESCALATION | 386,391 | CHUDAKOV | 1 | 1 | D | APP | EUGENE C |  | 544B | 10-053 | 10-077 | 11-006 | 11-026 |  |  |  |  |  |  |  |  |  |  |  |  |  |  |  |  |  |  |  |  |  |  |  |
| 1544070 |  | Racks - Production Parts (QTY 55) (CRATES/RACKS) | 83d | 2012-03-05 | 2012-06-29 | 1544065, 9-120M FS+100d | 246d | 0d | PROCUREMENT<$50K 60; PROCUREMENT>$50K 69 | 68,105.4 | CHUDAKOV | 1 | 1 | D | APP | EUGENE C |  | 544A |  |  | 11-006 | 11-026 | 12-021 | C | 12-054F |  |  |  |  |  |  |  |  |  |  |  |  |  |  |  |  |  |  |  |  |
| 1544075 |  | Racks - Production Acceptance (CRATES/RACKS) | 91d | 2012-04-12 | 2012-08-20 | 1544070 FS-55d | 246d | 143d | ELEC TECH [160 h] | 7,060.8 | CHUDAKOV | 1 | 1 | D | APP | EUGENE C |  | 544A |  |  | 11-006 | 11-026 | 12-021 | C | 12-054F |  |  |  |  |  |  |  |  |  |  |  |  |  |  |  |  |  |  |  |  |
| 1544015 |  | Vend Fab Crate supl (5 VXS and 2 VME64) | 168d | 2012-04-26 | 2012-12-31 | 9-120M FS+138d | 174d | 61d | PROCUREMENT<$50K 60 NO ESCALATION FY13; PROCUREMENT>$50K 69 NO ESCALATION FY13 | 70,000 | CHUDAKOV | 1 | 1 | D | APP | EUGENE C |  | 544A |  | 10-077 | 11-006 | 11-026 | 12-021 |  |  |  | 08-038 |  |  |  |  |  |  |  |  |  |  |  |  |  |  |  |  |  |  |
| 1544020 |  | Assemble ADC Crates (CRATES/RACKS) | 11d | 2012-07-02 | 2012-07-16 | 1544010, 1544006 | 264d | 0d | ELEC TECH [80 h] | 3,530.4 | CHUDAKOV | 1 | 1 | D |  | EUGENE C |  |  |  | 10-077 | 11-006 | 11-026 |  |  |  |  |  |  |  |  |  |  |  |  |  |  |  |  |  |  |  |  |  |  |  |
| 1544025 |  | Test ADC Crates (CRATES/RACKS) | 22d | 2012-07-17 | 2012-08-15 | 1544020 | 264d | 130d | ELEC TECH [360 h] | 15,886.8 | CHUDAKOV | 1 | 1 | D |  | EUGENE C |  |  |  | 10-077 | 11-006 | 11-026 |  |  |  |  |  |  |  |  |  |  |  |  |  |  |  |  |  |  |  |  |  |  |  |
| 1544080 |  | Re-Baseline Actuals Adjustment | 1d | 2013-08-30 | 2013-08-30 | 9-130M FS+227d | 20d |  | PROCUREMENT>$50K 69 NO ESCALATION | -29,853.89 | CHUDAKOV | 1 | 1 |  |  | EUGENE C |  |  |  |  |  |  |  |  |  |  |  |  | 13-014 | ADJ |  |  |  |  |  |  |  |  |  |  |  |  |  |  |  |
|  | 5 | **1.5.4.5 LOGIC, HV** |  | 2009-01-02 | 2013-08-30 |  |  |  |  |  |  |  |  |  |  |  |  |  |  |  |  |  |  |  |  |  |  |  |  |  |  |  |  |  |  |  |  |  |  |  |  |  |  |  |  |
| 1545009E |  | FY09 Travel (LOGIC, HV) | 189d | 2009-01-02 | 2009-09-30 | 1545009EX | 310d | 0d | TRAVEL | 973.93 | CHUDAKOV | 1 | 1 | D |  | EUGENE C |  |  |  |  | 11-006 | 11-026 |  |  |  |  |  |  |  |  | 07-024 | 07-027 | 08-058 | 11-029 |  |  |  |  |  |  |  |  |  |  |  |
| 1545010E |  | FY10 Travel (LOGIC, HV) | 248d | 2009-10-01 | 2010-09-30 | 1545009E | 310d | 0d | TRAVEL | 1,208.66 | CHUDAKOV | 1 | 1 | D |  | EUGENE C |  |  |  |  | 11-006 | 11-026 |  |  |  |  |  |  |  |  | 07-024 | 07-027 |  | 11-029 |  |  |  |  |  |  |  |  |  |  |  |
| 1545011E |  | FY11 Travel (LOGIC, HV) | 248d | 2010-10-01 | 2011-09-30 | 1545010E | 310d | 0d | TRAVEL | 1,247.22 | CHUDAKOV | 1 | 1 | D |  | EUGENE C |  |  |  |  | 11-006 | 11-026 |  |  |  |  |  |  |  |  | 07-024 | 07-027 |  | 11-029 |  |  |  |  |  |  |  |  |  |  |  |
| 1545040 |  | High Voltage - First Article Procurement Support | 24d | 2011-01-04 | 2011-02-07 | 9-110M FS+59d | 433d | 1d | ELEC ENG [240 h] | 16,411.2 | CHUDAKOV | 1 | 1 | D |  | EUGENE C |  |  |  |  | 11-006 | 11-026 |  |  |  |  |  | 09-012 |  |  |  |  |  | 11-029 | DUP |  |  |  |  |  |  |  |  |  |  |
| 1545050 |  | High Voltage - First Article Crates (QTY 1) and Modules (QTY 10) | 23d | 2011-01-05 | 2011-02-07 | 9-110M FS+60d, 1234180M, 1545040 FS-24d | 432d | 0d | PROCUREMENT<$50K 60; PROCUREMENT>$50K 69 | 76,620.04 | CHUDAKOV | 1 | 1 | D | APP | EUGENE C |  | 545 |  |  | 11-006 | 11-026 |  |  |  |  |  | 09-012 |  |  |  |  |  | 11-029 |  | 08-036 | 10-024 | 11-002 |  |  |  |  |  |  |  |
| 1545014 |  | Discriminator - First Article Procurement Support | 98d | 2011-01-10 | 2011-05-27 | 9-110M FS+63d, 1234180M | 194d | 0d | ELEC ENG [40 h]; ELEC TECH [160 h] | 9,578.4 | CHUDAKOV | 1 | 1 | D | APP | EUGENE C |  | 545 |  |  | 11-006 | 11-026 |  |  |  |  |  |  |  |  | 07-024 |  |  |  |  |  | 10-024 |  | IPL | 09-014 | 10-042 | 12-016 |  |  |  |
| 1545051 |  | High Voltage - First Article Crates Acceptance Tests (QTY 1) | 19d | 2011-02-22 | 2011-03-18 | 1545050a FS-60d, 1545050 FS+9d | 432d | 0d | ELEC ENG [40 h]; ELEC TECH [40 h] | 4,446 | CHUDAKOV | 1 | 1 | D | APP | EUGENE C |  | 545 |  |  | 11-006 | 11-026 |  |  |  |  |  | 09-012 |  |  |  |  |  | 11-029 |  | 08-036 | 10-024 | 11-002 |  |  |  |  |  |  |  |
| 1545090 |  | Low Voltage - First Article Procurement Support | 108d | 2011-03-07 | 2011-08-05 | 9-110M FS+101d | 230d | 0d | ELEC ENG [240 h] | 16,411.2 | CHUDAKOV | 1 | 1 | D |  | EUGENE C |  |  |  |  | 11-006 | 11-026 | 12-021F |  |  |  |  | 09-012 |  |  |  |  |  |  | DUP |  |  |  |  |  |  |  |  |  |  |
| 1545095 |  | Low Voltage - First Article Crates (QTY 1) | 108d | 2011-03-07 | 2011-08-05 | 1545090 FS-108d, 9-110M FS+60d | 230d | 0d | PROCUREMENT<$50K 60 | 6,300 | CHUDAKOV | 1 | 1 | D | APP | EUGENE C |  | 545 |  |  | 11-006 | 11-026 | 12-021F |  |  |  |  | 09-012 |  |  |  |  |  |  |  | 08-036 | 10-024 | 11-002 |  |  |  |  |  |  |  |
| 1545097 |  | Low Voltage - First Article Modules (QTY 8) | 108d | 2011-03-07 | 2011-08-05 | 1545090 FS-108d, 9-110M FS+60d | 250d | 20d | PROCUREMENT<$50K 60 | 45,200 | CHUDAKOV | 1 | 1 | D | APP | EUGENE C |  | 545 |  |  | 11-006 | 11-026 | 12-021F |  |  |  |  | 09-012 |  |  |  |  |  |  |  | 08-036 | 10-024 | 11-002 |  |  |  |  |  |  |  |
| 1545055 |  | High Voltage - First Article Modules Acceptance Tests (QTY 10) | 20d | 2011-03-14 | 2011-04-08 | 1545050a FS-50d, 1545050, 1545051 FS-5d | 432d | 122d | ELEC ENG [40 h]; ELEC TECH [120 h] | 7,867.6 | CHUDAKOV | 1 | 1 | D | APP | EUGENE C | 08-035 | 545 |  |  | 11-006 | 11-026 |  |  |  |  |  |  |  |  | 07-024 |  |  | 11-029 |  |  | 10-024 |  |  |  |  |  | 10-054 |  |  |
| 1545015 |  | Discriminator - First Article Parts Fab and Assembly (QTY 25) | 147d | 2011-03-28 | 2011-10-21 | 1234180M, 1545014 FS-45d | 194d | 0d | PROCUREMENT<$50K 60 NO ESCALATION FY12; PROCUREMENT>$50K 69 NO ESCALATION FY12 | 62,500 | CHUDAKOV | 1 | 1 | D | APP | EUGENE C |  | 545 |  |  | 11-006 | 11-026 |  |  |  |  |  |  |  |  | 07-024 |  |  |  |  |  | 10-024 |  | IPL | 09-014 | 10-042 | 12-016 |  |  |  |
| 1545017 |  | Test stand for testing/acceptance of discriminator | 64d | 2011-04-01 | 2011-06-30 | 9-110M FS+120d | 199d | 5d | ELEC ENG [200 h]; SCIENTIST [200 h] | 27,362 | CHUDAKOV | 1 | 1 | D |  | EUGENE C |  |  |  |  | 11-006 | 11-026 |  |  |  |  |  | 09-012 |  |  | 07-024 |  |  |  | DUP |  |  |  |  |  |  | 12-016 |  | 09-045 |  |
| 1545050a |  | High Voltage - First Article Crates (QTY 1) and Modules (added cost) | 28d | 2011-04-01 | 2011-05-11 | 1545050 FS+37.5d | 435.5d | 3.5d | PROCUREMENT>$50K 69 | 2,454 | CHUDAKOV | 1 | 1 | D | APP | EUGENE C |  | 545 |  |  | 11-006 | 11-026 |  |  |  |  |  | 09-012 |  |  |  |  |  | 11-029 |  | 08-036 | 10-024 | 11-002 |  |  |  |  |  |  |  |
| 1545020 |  | Discriminator - First Article Test (QTY 25) FY11 | 59d | 2011-07-11 | 2011-09-30 | 1545017, 1545015 FS-74d | 194d | 0d | ELEC ENG [20.17 h]; ELEC TECH [242.05 h] | 11,731.7 | CHUDAKOV | 1 | 1 | D |  | EUGENE C |  |  |  |  | 11-006 | 11-026 |  |  |  | 12-001 |  |  |  |  | 07-024 | 07-027 |  |  |  |  |  |  |  | 09-014 | 10-042 | 12-016 |  |  |  |
| 1545098 |  | Low Voltage - First Article Crates Acceptance Tests (QTY 1) | 20d | 2011-08-08 | 2011-09-02 | 1545095 | 230d | 0d | ELEC TECH [40 h]; ELEC ENG [40 h] | 4,446 | CHUDAKOV | 1 | 1 | D | APP | EUGENE C |  | 545 |  |  | 11-006 | 11-026 | 12-021F |  |  |  |  | 09-012 |  |  |  |  |  |  |  | 08-036 | 10-024 | 11-002 |  |  |  |  |  |  |  |
| 1545100 |  | Low Voltage - First Article Modules Acceptance Tests (QTY 10) | 19d | 2011-09-06 | 2011-09-30 | 1545097, 1545098 | 230d | 5d | ELEC ENG [40 h]; ELEC TECH [120 h] | 7,867.6 | CHUDAKOV | 1 | 1 | D | APP | EUGENE C | 08-035 | 545 |  |  | 11-006 | 11-026 | 12-021F |  |  |  |  |  |  |  | 07-024 |  |  |  |  |  | 10-024 |  |  |  |  |  | 10-054 |  |  |
| 1545005 |  | Assemble Signal Distrbtn CFD Tests (LOGIC, HV) | 20d | 2011-10-03 | 2011-10-28 | 9-120M, 1234180M | 396d | 0d |  |  | CHUDAKOV | 1 | 1 | D |  | EUGENE C |  |  |  |  | 11-006 | 11-026 |  |  |  |  |  | 09-012 |  |  | 07-024 |  |  |  | DUP |  |  |  |  |  |  |  |  |  |  |
| 1545020a |  | Discriminator - First Article Test (QTY 25) FY12 | 58d | 2011-10-03 | 2011-12-30 | 1545020 | 194d | 0d | ELEC TECH [237.95 h]; ELEC ENG [19.83 h] | 11,899.93 | CHUDAKOV | 1 | 1 | D |  | EUGENE C |  |  |  |  | 11-006 | 11-026 |  |  |  | 12-001 |  |  |  |  | 07-024 | 07-027 |  |  |  |  |  |  |  | 09-014 | 10-042 | 12-016 |  |  |  |
| 1545060 |  | High Voltage - Production Procurement Support | 100d | 2011-10-03 | 2012-03-02 | 9-120M, 1545055 | 310d | 0d | ELEC TECH [40 h] | 1,765.2 | CHUDAKOV | 1 | 1 | D |  | EUGENE C |  |  |  |  | 11-006 | 11-026 |  |  |  |  |  |  |  |  | 07-024 | 07-027 |  | 11-029 |  |  |  | 11-002 |  |  |  |  |  |  |  |
| 1545065 |  | Vend Fab - Universal Multichannel Power Supply System 750W (QTY 6) | 130d | 2011-10-03 | 2012-04-13 | 1545060 FS-100d, 9-120M, 1545011E | 310d | 0d | PROCUREMENT<$50K 60; PROCUREMENT>$50K 69 | 52,213.13 | CHUDAKOV | 1 | 1 | D |  | EUGENE C |  |  |  |  | 11-006 | 11-026 |  |  |  |  |  |  |  |  | 07-024 | 07-027 |  | 11-029 |  |  |  | 11-002 |  |  |  |  |  |  |  |
| 1545066 |  | Vend Fab - Optional Power Supply 750W (QTY 6) | 130d | 2011-10-03 | 2012-04-13 | 1545065 FS-130d | 310d | 0d | PROCUREMENT>$50K 69 | 8,210.85 | CHUDAKOV | 1 | 1 | D |  | EUGENE C |  |  |  |  | 11-006 | 11-026 |  |  |  |  |  |  |  |  | 07-024 | 07-027 |  | 11-029 |  |  |  | 11-002 |  |  |  |  |  |  |  |
| 1545070 |  | Vend Fab - H.V Channels -3.5 KV 3 MA SHV Floating (QTY 18) | 130d | 2011-10-03 | 2012-04-13 | 1545066 FS-130d | 310d | 0d | PROCUREMENT>$50K 69 | 124,270.13 | CHUDAKOV | 1 | 1 | D |  | EUGENE C |  |  |  |  | 11-006 | 11-026 |  |  |  |  |  |  |  |  |  |  |  | 11-029 |  |  |  |  |  |  |  |  |  |  |  |
| 1545071 |  | Vend Fab - H.V Channels +3.5 KV 3 MA Floating (QTY 8) | 130d | 2011-10-03 | 2012-04-13 | 1545070 FS-130d | 310d | 0d | PROCUREMENT>$50K 69 | 55,981.65 | CHUDAKOV | 1 | 1 | D |  | EUGENE C |  |  |  |  | 11-006 | 11-026 |  |  |  |  |  |  |  |  | 07-024 | 07-027 |  | 11-029 |  |  |  | 11-002 |  |  |  |  |  |  |  |
| 1545075 |  | Vend Fab - H.V Channels -3.5 KV 3 MA Floating (QTY 3) | 130d | 2011-10-03 | 2012-04-13 | 1545071 FS-130d | 310d | 0d | PROCUREMENT>$50K 69 | 21,677.11 | CHUDAKOV | 1 | 1 | D |  | EUGENE C |  |  |  |  | 11-006 | 11-026 |  |  |  |  |  |  |  |  | 07-024 | 07-027 |  | 11-029 |  |  |  | 11-002 |  |  |  |  |  |  |  |
| 1545105 |  | Low Voltage - Production Procurement Support | 51d | 2011-10-10 | 2011-12-21 | 1545100, 9-120M FS+5d | 225d | 20d | ELEC ENG [40 h] | 2,822.4 | CHUDAKOV | 1 | 1 | D |  | EUGENE C |  |  |  |  | 11-006 | 11-026 | 12-021F |  |  |  |  |  |  |  | 07-024 | 07-027 |  |  |  |  |  | 11-002 |  |  |  |  |  |  |  |
| 1545022 |  | Discriminator - Full Single-Crate Acceptance Test | 43d | 2011-10-24 | 2011-12-30 | 1545020a FS-43d | 194d | 0d | ELEC TECH [160 h]; ELEC ENG [40 h] | 9,883.2 | CHUDAKOV | 1 | 1 | D |  | EUGENE C |  |  |  |  | 11-006 | 11-026 |  |  |  |  |  |  |  |  | 07-024 | 07-027 |  |  |  |  |  |  |  | 09-014 | 10-042 | 12-016 |  |  |  |
| 1545010 |  | Dry Run of Testing Procedures for CFDs (LOGIC, HV) | 6d | 2011-10-31 | 2011-11-07 | 1545005 | 396d | 202d |  |  | CHUDAKOV | 1 | 1 | D |  | EUGENE C |  |  |  |  | 11-006 | 11-026 |  |  |  |  |  | 09-012 |  |  | 07-024 |  |  | 11-029 | DUP |  |  |  |  |  |  |  |  |  |  |
| 1545110 |  | Low Voltage - Crates Production (QTY 7) | 245d | 2011-11-07 | 2012-10-31 | 9-120M FS+25d, 1545105 FS-51d | 205d | 0d | PROCUREMENT<$50K 60 NO ESCALATION FY13 | 45,506.79 | CHUDAKOV | 1 | 1 | D |  | EUGENE C |  |  |  |  | 11-006 | 11-026 | 12-021 |  |  |  |  |  |  |  | 07-024 | 07-027 |  |  |  |  |  | 11-002 |  |  |  |  |  |  |  |
| 1545115 |  | Low Voltage - Modules Production (QTY 38) | 245d | 2011-11-07 | 2012-10-31 | 1545110 FS-245d, 9-120M | 205d | 0d | PROCUREMENT<$50K 60 NO ESCALATION FY13; PROCUREMENT>$50K 69 NO ESCALATION FY13 | 195,235.48 | CHUDAKOV | 1 | 1 | D |  | EUGENE C |  |  |  |  | 11-006 | 11-026 | 12-021 |  |  |  |  |  |  |  |  |  |  |  |  |  |  |  |  |  |  |  |  |  |  |
| 1545025 |  | Discriminator - Production Procurement Support | 57d | 2012-01-03 | 2012-03-23 | 1545022 | 194d | 0d | ELEC TECH [400 h] | 17,652 | CHUDAKOV | 1 | 1 | D |  | EUGENE C |  |  |  |  | 11-006 | 11-026 |  |  |  |  |  |  |  |  | 07-024 | 07-027 |  |  |  |  |  |  |  | 09-014 | 10-042 | 12-016 |  |  |  |
| 1545026 |  | Discriminator - Production Parts Non-Recurring Engineering | 104d | 2012-01-04 | 2012-05-31 | 9-120M FS+59d | 194d | 0d | PROCUREMENT<$50K 60 NO ESCALATION; PROCUREMENT>$50K 69 NO ESCALATION | 750.6 | CHUDAKOV | 1 | 1 | D |  | EUGENE C |  |  |  |  |  |  |  |  |  |  |  |  |  |  |  |  |  |  |  |  |  |  |  |  |  | 12-016 |  |  |  |
| 1545027 |  | Discriminator - Production Parts Fab and Assembly (QTY 70) | 169d | 2012-01-04 | 2012-08-31 | 1545026 FS-104d, 1545025 FS-56d | 194d | 0d | PROCUREMENT<$50K 60 NO ESCALATION; PROCUREMENT>$50K 69 NO ESCALATION | 103,125.7 | CHUDAKOV | 1 | 1 | D |  | EUGENE C |  |  |  |  | 11-006 | 11-026 |  |  |  |  |  |  |  |  | 07-024 | 07-027 |  |  |  |  |  |  |  | 09-014 | 10-042 | 12-016 |  |  |  |
| 1545080 |  | High Voltage - Crates Production Tests (QTY 6) | 73d | 2012-02-22 | 2012-06-05 | 1545066 FS-38d, 1545065 FS-38d | 310d | 0d | ELEC TECH [80 h] | 3,530.4 | CHUDAKOV | 1 | 1 | D |  | EUGENE C |  |  |  |  | 11-006 | 11-026 |  |  |  |  |  |  |  |  |  |  |  | 11-029 |  |  |  |  |  |  |  |  |  |  |  |
| 1545085 |  | High Voltage - Modules Production Tests (QTY 29) | 73d | 2012-02-22 | 2012-06-05 | 1545075 FS-38d | 310d | 0d | ELEC TECH [320 h] | 14,121.6 | CHUDAKOV | 1 | 1 | D |  | EUGENE C |  |  |  |  | 11-006 | 11-026 |  |  |  |  |  |  |  |  |  |  |  | 11-029 |  |  |  |  |  |  |  |  |  |  |  |
| 1545120 |  | Low Voltage - Crates Production Tests (QTY 7) FY12 | 112d | 2012-04-23 | 2012-09-28 | 1545110 FS-135d | 205d | 0d | ELEC TECH [66.37 h] | 2,928.91 | CHUDAKOV | 1 | 1 | D |  | EUGENE C |  |  |  |  | 11-006 | 11-026 | 12-021 |  |  |  |  |  |  |  |  |  |  |  |  |  |  |  |  |  |  |  |  |  | 12-053 |
| 1545125 |  | Low Voltage - Modules Production Tests (QTY 38) FY12 | 112d | 2012-04-23 | 2012-09-28 | 1545115 FS-135d | 205d | 0d | ELEC TECH [265.48 h] | 11,715.63 | CHUDAKOV | 1 | 1 | D |  | EUGENE C |  |  |  |  | 11-006 | 11-026 | 12-021 |  |  |  |  |  |  |  |  |  |  |  |  |  |  |  |  |  |  |  |  |  | 12-053 |
| 1545028 |  | Procure Discriminators (Qty.24) Supplemental BCAL and PS | 109d | 2012-08-20 | 2013-01-31 | 9-120M FS+218d | 153d | 19d | PROCUREMENT<$50K 60 NO ESCALATION FY13 | 48,000 | CHUDAKOV | 1 | 1 | D |  | EUGENE C |  |  |  |  | 11-006 | 11-026 | 12-021 |  |  |  |  |  |  |  |  |  |  |  |  |  |  |  |  |  |  |  |  |  |  |
| 1545030 |  | Discriminator - Production Test (QTY 70) FY12 | 19d | 2012-09-04 | 2012-09-28 | 1545010, 1545027 | 194d | 0d | ELEC TECH [157.24 h] | 6,939 | CHUDAKOV | 1 | 1 | D |  | EUGENE C |  |  |  |  | 11-006 | 11-026 |  |  |  |  |  |  |  |  | 07-024 | 07-027 |  |  |  |  |  |  |  | 09-014 | 10-042 | 12-016 |  |  | 12-053 |
| 1545030a |  | Discriminator - Production Test (QTY 70) FY13 | 39d | 2012-10-01 | 2012-11-26 | 1545030 | 194d | 60d | ELEC TECH [322.76 h] | 14,698.49 | CHUDAKOV | 1 | 1 | D |  | EUGENE C |  |  |  |  | 11-006 | 11-026 |  |  |  |  |  |  |  |  | 07-024 | 07-027 |  |  |  |  |  |  |  | 09-014 | 10-042 | 12-016 |  |  | 12-053 |
| 1545120a |  | Low Voltage - Crates Production Tests (QTY 7) FY13 | 23d | 2012-10-01 | 2012-10-31 | 1545120 | 205d | 76d | ELEC TECH [13.63 h] | 620.71 | CHUDAKOV | 1 | 1 | D |  | EUGENE C |  |  |  |  | 11-006 | 11-026 | 12-021 |  |  |  |  |  |  |  |  |  |  |  |  |  |  |  |  |  |  |  |  |  | 12-053 |
| 1545125a |  | Low Voltage - Modules Production Tests (QTY 38) FY13 | 23d | 2012-10-01 | 2012-10-31 | 1545125, 1545115 FS-135d | 205d | 76d | ELEC TECH [54.52 h] | 2,482.84 | CHUDAKOV | 1 | 1 | D |  | EUGENE C |  |  |  |  | 11-006 | 11-026 | 12-021 |  |  |  |  |  |  |  |  |  |  |  |  |  |  |  |  |  |  |  |  |  | 12-053 |
| 1545130 |  | Re-Baseline Actuals Adjustment | 1d | 2013-08-30 | 2013-08-30 | 9-130M FS+227d | 20d |  | PROCUREMENT>$50K 69 NO ESCALATION | -218,552.68 | CHUDAKOV | 1 | 1 |  |  | EUGENE C |  |  |  |  |  |  |  |  |  |  |  |  | 13-014 | ADJ |  |  |  |  |  |  |  |  |  |  |  |  |  |  |  |

Notes:
- 1545014: Explanation: IPL from 6 GeV 5545040M
- 1545015: Explanation: IPL from 6 GeV 5545040M

| ID | WBS | Activity | Duration | Start | Finish | Predecessors | Total float | Free float | Resources | Cost | RESP - Responsibility | STRT%COMP for CM EVM | FNSH%COMP for CM EVM | HALL D Related Milestones | CAM RESPONSIBLE | CR 11-006 | CR 11-026 | CR 12-054 | CR 12-001 | CR 12-021 | CR 12-053 |
| --- | --- | --- | --- | --- | --- | --- | --- | --- | --- | --- | --- | --- | --- | --- | --- | --- | --- | --- | --- | --- | --- |
|  | 6 | **1.5.4.6 DETECTOR ELECTRONICS** |  | 2011-01-04 | 2014-09-30 |  |  |  |  |  |  |  |  |  |  |  |  |  |  |  |  |
| 1546005 |  | ASIC - Procurement Support (FDC&CDC) | 42d | 2011-01-04 | 2011-03-04 | 9-110M FS+59d | 77d | 0d | ELEC ENG [200 h] | 13,676 | CHUDAKOV | 1 | 1 | D | EUGENE C | 11-006 | 11-026 | 12-054F |  |  |  |
| 1546020 |  | ASIC - Test Fixture Development (FDC&CDC) | 33d | 2011-01-18 | 2011-03-04 | 9-110M FS+68d | 92d | 0d | ELEC TECH [240 h]; ELEC ENG [40 h] | 13,000 | CHUDAKOV | 1 | 1 | D | EUGENE C | 11-006 | 11-026 | 12-054F |  |  |  |
| 1546125 |  | HVB - Development Revisions (CDC) | 43d | 2011-01-24 | 2011-03-24 | 9-110M FS+72d | 55d | 0d | ELEC ENG [160 h] | 10,940.8 | CHUDAKOV | 1 | 1 | D | EUGENE C | 11-006 | 11-026 | 12-054F |  |  |  |
| 1546140 |  | HVB - First Article Procurement Support (CDC) | 59d | 2011-01-24 | 2011-04-15 | 9-110M FS+72d | 55d | 0d | ELEC ENG [40 h]; ELEC TECH [80 h] | 6,156.8 | CHUDAKOV | 1 | 1 | D | EUGENE C | 11-006 | 11-026 | 12-054F |  |  |  |
| 1546145 |  | HVB - First Article Parts (CDC) | 122d | 2011-01-24 | 2011-07-15 | 1546140 FS-59d | 55d | 0d | PROCUREMENT<$50K 60 | 10,000 | CHUDAKOV | 1 | 1 | D | EUGENE C | 11-006 | 11-026 | 12-054F |  |  |  |
| 1546025 |  | ASIC - Test Fixture Procurement Support (FDC&CDC) | 15d | 2011-03-07 | 2011-03-25 | 1546020 | 97d | 5d | ELEC TECH [80 h] | 3,421.6 | CHUDAKOV | 1 | 1 | D | EUGENE C | 11-006 | 11-026 | 12-054F |  |  |  |
| 1546030 |  | ASIC - Test Fixture Parts (FDC&CDC) | 10d | 2011-03-07 | 2011-03-18 | 1546020 | 92d | 0d | PROCUREMENT<$50K 60 | 10,000 | CHUDAKOV | 1 | 1 | D | EUGENE C | 11-006 | 11-026 | 12-054F |  |  |  |
| 1546130 |  | HVB - Development PCB Fab Files (CDC) | 5d | 2011-03-14 | 2011-03-18 | 1546125 FS-9d | 55d | 0d | ELEC ENG [40 h] | 2,735.2 | CHUDAKOV | 1 | 1 | D | EUGENE C | 11-006 | 11-026 | 12-054F |  |  |  |
| 1546135 |  | HVB - Development PCB Assembly Files (CDC) | 5d | 2011-03-14 | 2011-03-18 | 1546125 FS-9d, 1546130 FS-5d | 55d | 0d | ELEC ENG [40 h] | 2,735.2 | CHUDAKOV | 1 | 1 | D | EUGENE C | 11-006 | 11-026 | 12-054F |  |  |  |
| 1546035 |  | ASIC - Test Fixture Fab (FDC&CDC) | 10d | 2011-03-21 | 2011-04-01 | 1546030 | 92d | 0d | PROCUREMENT<$50K 60 | 2,000 | CHUDAKOV | 1 | 1 | D | EUGENE C | 11-006 | 11-026 | 12-054F |  |  |  |
| 1546095 |  | Preamp Card - Test Fixture Development (FDC&CDC) | 40d | 2011-03-21 | 2011-05-13 | 9-110M FS+111d | 59d | 0d | ELEC ENG [40 h]; ELEC TECH [240 h] | 13,000 | CHUDAKOV | 1 | 1 | D | EUGENE C | 11-006 | 11-026 | 12-054F |  |  |  |
| 1546150 |  | HVB - First Article Fab 2 Units (CDC) | 10d | 2011-03-21 | 2011-04-01 | 1546135, 1546145 FS-83d | 55d | 0d | PROCUREMENT<$50K 60 | 2,000 | CHUDAKOV | 1 | 1 | D | EUGENE C | 11-006 | 11-026 | 12-054F |  |  |  |
| 1546040 |  | ASIC - Test Fixture Assembly (FDC&CDC) | 10d | 2011-04-04 | 2011-04-15 | 1546025, 1546035 | 92d | 0d | ELEC TECH [80 h] | 3,421.6 | CHUDAKOV | 1 | 1 | D | EUGENE C | 11-006 | 11-026 | 12-054F |  |  |  |
| 1546155 |  | HVB - First Article Assembly 2 Units (CDC) | 10d | 2011-04-04 | 2011-04-15 | 1546150 | 55d | 0d | ELEC TECH [40 h] | 1,710.8 | CHUDAKOV | 1 | 1 | D | EUGENE C | 11-006 | 11-026 | 12-054F |  |  |  |
| 1546050 |  | Preamp Card - First Article Procurement Support (FDC&CDC) | 59d | 2011-04-11 | 2011-07-01 | 9-110M FS+126d | 20d | 0d | ELEC TECH [200 h]; ELEC ENG [40 h] | 11,289.2 | CHUDAKOV | 1 | 1 | D | EUGENE C | 11-006 | 11-026 | 12-054F |  |  |  |
| 1546055 |  | Preamp Card - First Article Parts (FDC&CDC) | 59d | 2011-04-11 | 2011-07-01 | 1546050 FS-59d, 9-110M FS+126d | 20d | 0d | PROCUREMENT<$50K 60 | 25,000 | CHUDAKOV | 1 | 1 | D | EUGENE C | 11-006 | 11-026 | 12-054F |  |  |  |
| 1546045 |  | ASIC - Test Fixture Test (FDC&CDC) | 15d | 2011-04-18 | 2011-05-06 | 1546040 | 92d | 15d | ELEC TECH [80 h]; ELEC ENG [40 h] | 6,156.8 | CHUDAKOV | 1 | 1 | D | EUGENE C | 11-006 | 11-026 | 12-054F |  |  |  |
| 1546160 |  | HVB - First Article Test 2 Units (CDC) | 10d | 2011-04-18 | 2011-04-29 | 1546155 | 55d | 0d | ELEC TECH [40 h] | 1,710.8 | CHUDAKOV | 1 | 1 | D | EUGENE C | 11-006 | 11-026 | 12-054F |  |  |  |
| 1546165 |  | HVB - Production Procurement Support (CDC) | 58d | 2011-05-02 | 2011-07-22 | 1546160 | 55d | 0d | ELEC TECH [80 h]; ELEC ENG [160 h] | 14,362.4 | CHUDAKOV | 1 | 1 | D | EUGENE C | 11-006 | 11-026 | 12-054F |  |  |  |
| 1546100 |  | Preamp Card - Test Fixture Procurement Support (FDC&CDC) | 14d | 2011-05-16 | 2011-06-03 | 1546095 | 59d | 0d | ELEC TECH [80 h] | 3,421.6 | CHUDAKOV | 1 | 1 | D | EUGENE C | 11-006 | 11-026 | 12-054F |  |  |  |
| 1546105 |  | Preamp Card - Test Fixture Parts (FDC&CDC) | 19d | 2011-05-16 | 2011-06-10 | 1546100 FS-14d, 1546095 | 59d | 0d | PROCUREMENT<$50K 60 | 10,000 | CHUDAKOV | 1 | 1 | D | EUGENE C | 11-006 | 11-026 | 12-054F |  |  |  |
| 1546185 |  | HVB - Test Fixture Development (CDC) | 15d | 2011-05-27 | 2011-06-17 | 9-110M FS+160d | 79d | 0d | ELEC ENG [40 h]; ELEC TECH [40 h] | 4,446 | CHUDAKOV | 1 | 1 | D | EUGENE C | 11-006 | 11-026 | 12-054F |  |  |  |
| 1546010 |  | ASIC - Test (FDC&CDC) | 68d | 2011-05-31 | 2011-09-02 | 15211035b, 1546045 | 77d | 57d | ELEC TECH [280 h]; ELEC ENG [160 h] | 22,916.4 | CHUDAKOV | 1 | 1 | D | EUGENE C | 11-006 | 11-026 | 12-054F |  |  |  |
| 1546060 |  | Preamp Card - First Article Fab (FDC&CDC) | 39d | 2011-06-06 | 2011-07-29 | 1546055 FS-20d | 20d | 0d | PROCUREMENT<$50K 60 | 3,500 | CHUDAKOV | 1 | 1 | D | EUGENE C | 11-006 | 11-026 | 12-054F |  |  |  |
| 1546110 |  | Preamp Card - Test Fixture Fab (FDC&CDC) | 15d | 2011-06-13 | 2011-07-01 | 1546105 | 59d | 0d | PROCUREMENT<$50K 60 | 2,000 | CHUDAKOV | 1 | 1 | D | EUGENE C | 11-006 | 11-026 | 12-054F |  |  |  |
| 1546190 |  | HVB - Test Fixture Procurement Support (CDC) | 14d | 2011-06-20 | 2011-07-08 | 1546185 | 79d | 0d | ELEC TECH [40 h] | 1,710.8 | CHUDAKOV | 1 | 1 | D | EUGENE C | 11-006 | 11-026 | 12-054F |  |  |  |
| 1546195 |  | HVB - Test Fixture Parts (CDC) | 19d | 2011-06-20 | 2011-07-15 | 1546185, 1546190 FS-14d | 79d | 0d | PROCUREMENT<$50K 60 | 1,000 | CHUDAKOV | 1 | 1 | D | EUGENE C | 11-006 | 11-026 | 12-054F |  |  |  |
| 1546115 |  | Preamp Card - Test Fixture Assembly (FDC&CDC) | 9d | 2011-07-05 | 2011-07-15 | 1546110 | 59d | 0d | ELEC TECH [80 h] | 3,421.6 | CHUDAKOV | 1 | 1 | D | EUGENE C | 11-006 | 11-026 | 12-054F |  |  |  |
| 1546120 |  | Preamp Card - Test Fixture Test (FDC&CDC) | 10d | 2011-07-18 | 2011-07-29 | 1546115 | 59d | 39d | ELEC TECH [80 h] | 3,421.6 | CHUDAKOV | 1 | 1 | D | EUGENE C | 11-006 | 11-026 | 12-054F |  |  |  |
| 1546200 |  | HVB - Test Fixture Fab (CDC) | 15d | 2011-07-18 | 2011-08-05 | 1546195 | 79d | 0d | PROCUREMENT<$50K 60 | 2,000 | CHUDAKOV | 1 | 1 | D | EUGENE C | 11-006 | 11-026 | 12-054F |  |  |  |
| 1546170 |  | HVB - Production Fab (CDC) | 25d | 2011-07-25 | 2011-08-26 | 1546165 | 55d | 0d | PROCUREMENT<$50K 60 | 10,000 | CHUDAKOV | 1 | 1 | D | EUGENE C | 11-006 | 11-026 | 12-054F |  |  |  |
| 1546065 |  | Preamp Card - First Article Assembly (FDC&CDC) | 39d | 2011-08-01 | 2011-09-23 | 1546060 | 20d | 0d | PROCUREMENT<$50K 60 | 5,000 | CHUDAKOV | 1 | 1 | D | EUGENE C | 11-006 | 11-026 | 12-054F |  |  |  |
| 1546205 |  | HVB - Test Fixture Assembly (CDC) | 10d | 2011-08-08 | 2011-08-19 | 1546200 | 79d | 0d | ELEC TECH [80 h] | 3,421.6 | CHUDAKOV | 1 | 1 | D | EUGENE C | 11-006 | 11-026 | 12-054F |  |  |  |
| 1546210 |  | HVB - Test Fixture Test (CDC) | 10d | 2011-08-22 | 2011-09-02 | 1546205 | 79d | 24d | ELEC TECH [40 h] | 1,710.8 | CHUDAKOV | 1 | 1 | D | EUGENE C | 11-006 | 11-026 | 12-054F |  |  |  |
| 1546175 |  | HVB - Production Assembly (CDC) | 29d | 2011-08-29 | 2011-10-07 | 1546170 | 55d | 0d | PROCUREMENT<$50K 60 NO ESCALATION FY12 | 10,000 | CHUDAKOV | 1 | 1 | D | EUGENE C | 11-006 | 11-026 | 12-054F |  |  |  |
| 1546070 |  | Preamp Card - First Article Acceptance QA (FDC&CDC) FY11 | 5d | 2011-09-26 | 2011-09-30 | 1546120, 1546065 | 20d | 0d | ELEC ENG [16 h]; ELEC TECH [24 h] | 2,120.56 | CHUDAKOV | 1 | 1 | D | EUGENE C | 11-006 | 11-026 | 12-054F | 12-001 |  |  |
| 1546070a |  | Preamp Card - First Article Acceptance QA (FDC&CDC) FY12 | 20d | 2011-10-03 | 2011-10-28 | 1546070 | 20d | 0d | ELEC ENG [64 h]; ELEC TECH [96 h] | 8,752.32 | CHUDAKOV | 1 | 1 | D | EUGENE C | 11-006 | 11-026 | 12-054F | 12-001 |  |  |
| 1546180 |  | HVB - Production Test (CDC) | 71d | 2011-10-10 | 2012-01-27 | 1546210, 1546175 | 55d | 0d | ELEC TECH [320 h]; ELEC ENG [40 h] | 16,944 | CHUDAKOV | 1 | 1 | D | EUGENE C | 11-006 | 11-026 | 12-054F |  |  |  |
| 1546075 |  | Preamp Card - Production Procurement Support (FDC&CDC) | 51d | 2011-10-31 | 2012-01-20 | 1546070a | 20d | 0d | ELEC TECH [80 h] | 3,530.4 | CHUDAKOV | 1 | 1 | D | EUGENE C | 11-006 | 11-026 | 12-054F |  |  |  |
| 1546080 |  | Preamp Card - Production Fab (FDC&CDC) | 18d | 2011-10-31 | 2011-11-23 | 1546075 FS-51d, 1546070a | 20d | 0d | PROCUREMENT<$50K 60 | 22,701.8 | CHUDAKOV | 1 | 1 | D | EUGENE C | 11-006 | 11-026 | 12-054F |  |  |  |
| 1546085 |  | Preamp Card - Production Assembly (FDC&CDC) | 33d | 2011-11-28 | 2012-01-20 | 1546080, 1546010 | 20d | 0d | PROCUREMENT<$50K 60 | 23,733.7 | CHUDAKOV | 1 | 1 | D | EUGENE C | 11-006 | 11-026 | 12-054F |  |  |  |
| 1546090 |  | Preamp Card - Production Tests (FDC&CDC) | 107d | 2012-01-23 | 2012-06-22 | 1546085, 1546120 | 20d | 0d | ELEC TECH [880 h] | 38,834.4 | CHUDAKOV | 1 | 1 | D | EUGENE C | 11-006 | 11-026 | 12-054F |  |  |  |
| 1546300 |  | BCAL Readout Procurement Support | 137d | 2012-02-21 | 2012-08-31 | 9-120M FS+91d | 213d | 0d | ELEC ENG [272 h] | 19,192.32 | CHUDAKOV | 1 | 1 | D | EUGENE C | 11-006 | 11-026 |  |  | 12-021 |  |
| 1546390 |  | Power Distribution Engineering | 46d | 2012-02-27 | 2012-04-30 | 9-120M FS+95d | 300d | 87d | ELEC ENG [136 h] | 9,596.16 | CHUDAKOV | 1 | 1 | D | EUGENE C | 11-006 | 11-026 |  |  | 12-021 |  |
| 1546500 |  | Start Counter Engineering | 20d | 2012-02-27 | 2012-03-23 | 9-120M FS+95d | 216d | 0d | ELEC ENG [136 h] | 9,596.16 | CHUDAKOV | 1 | 1 | D | EUGENE C | 11-006 | 11-026 |  |  | 12-021 |  |
| 1546182 |  | Testing/manufacturing equipment for electronic boards | 147d | 2012-03-05 | 2012-09-28 | 9-120M FS+100d | 496d |  | PROCUREMENT<$50K 60 | 5,000 | CHUDAKOV | 1 | 1 | D | EUGENE C | 11-006 | 11-026 |  |  | 12-021 |  |
| 1546305 |  | Procure BCAL Readout V3 (Qty.96) $$ Reside @ 15221160ab per CR12-021 | 78d | 2012-03-12 | 2012-06-29 | 15221161c FS-500d, 15221161h FS-500d, 15221161a FS-307d, 1546300 FS-123d, 15221161n FS-500d, 15221161f FS-500d, 15221161s FS-500d, 15221161j FS-500d, 15221161b FS-500d, 15221161k FS-500d | 213d | 0d |  |  | CHUDAKOV | 1 | 1 | D | EUGENE C | 11-006 | 11-026 |  |  | 12-021 |  |
| 1546310 |  | Procure U-Boards (Qty.3840) | 58d | 2012-03-12 | 2012-05-31 | 1546305 FS-78d | 213d | 0d | PROCUREMENT<$50K 60; PROCUREMENT>$50K 69 | 100,680 | CHUDAKOV | 1 | 1 | D | EUGENE C | 11-006 | 11-026 |  |  | 12-021 |  |
| 1546400 |  | Pair Spectrometer Engineering | 30d | 2012-03-19 | 2012-04-27 | 9-120M FS+110d | 160d | 0d | ELEC ENG [96 h] | 6,773.76 | CHUDAKOV | 1 | 1 | D | EUGENE C | 11-006 | 11-026 |  |  | 12-021 |  |
| 1546505 |  | Start Counter Prototype Procurement Prep | 10d | 2012-03-26 | 2012-04-06 | 1546500 | 216d | 0d | ELEC ENG [68 h] | 4,798.08 | CHUDAKOV | 1 | 1 | D | EUGENE C | 11-006 | 11-026 |  |  | 12-021 |  |
| 1546510 |  | Start Counter Prototype Parts,Fab and Assembly | 25d | 2012-03-26 | 2012-04-27 | 1546505 FS-10d | 216d | 0d | ELEC TECH [68 h]; PROCUREMENT<$50K 60 | 8,000.84 | CHUDAKOV | 1 | 1 | D | EUGENE C | 11-006 | 11-026 |  |  | 12-021 |  |
| 1546405 |  | Pair Spectrometer Prototype Procurement Prep | 25d | 2012-04-16 | 2012-05-18 | 1546400 FS-10d | 160d | 0d | ELEC ENG [96 h] | 6,773.76 | CHUDAKOV | 1 | 1 | D | EUGENE C | 11-006 | 11-026 | 12-054F |  | 12-021 |  |
| 1546315 |  | Procure Thermistor Boards (Qty.384) | 28d | 2012-04-23 | 2012-05-31 | 1546310 FS-28d | 213d | 0d | PROCUREMENT<$50K 60 | 19,706 | CHUDAKOV | 1 | 1 | D | EUGENE C | 11-006 | 11-026 |  |  | 12-021 |  |
| 1546410 |  | Pair Spectrometer Prototype Parts,Fab and Assembly | 38d | 2012-04-23 | 2012-06-15 | 1546405 FS-20d | 160d | 0d | ELEC TECH [68 h]; PROCUREMENT<$50K 60 | 8,000.84 | CHUDAKOV | 1 | 1 | D | EUGENE C | 11-006 | 11-026 | 12-054F |  | 12-021 |  |
| 1546320 |  | Procure Transition Boards (Qty.96) | 38d | 2012-05-07 | 2012-06-29 | 1546315 FS-18d | 213d | 0d | PROCUREMENT<$50K 60 | 45,032 | CHUDAKOV | 1 | 1 | D | EUGENE C | 11-006 | 11-026 |  |  | 12-021 |  |
| 1546325 |  | Procure Power Distribution (Qty.18) | 78d | 2012-05-14 | 2012-08-31 | 1546320 FS-33d | 213d | 0d | PROCUREMENT<$50K 60 | 11,700 | CHUDAKOV | 1 | 1 | D | EUGENE C | 11-006 | 11-026 |  |  | 12-021 |  |
| 1546515 |  | Test Start Counter Prototype | 14d | 2012-05-14 | 2012-06-01 | 1546510 FS+10d | 216d | 174d | ELEC ENG [28 h]; ELEC TECH [68 h] | 4,976.52 | CHUDAKOV | 1 | 1 | D | EUGENE C | 11-006 | 11-026 |  |  | 12-021 |  |
| 1546360 |  | Test BCAL Readout V3 | 51d | 2012-06-11 | 2012-08-20 | 1546305 FS-15d | 228d | 0d | ELEC TECH [272 h]; ELEC ENG [68 h] | 16,801.44 | CHUDAKOV | 1 | 1 | D | EUGENE C | 11-006 | 11-026 |  |  | 12-021 |  |
| 1546365 |  | Test U-Boards FY12 | 79d | 2012-06-11 | 2012-09-28 | 1546360 FS-51d, 1546310 | 228d | 0d | ELEC TECH [505.6 h] | 22,312.13 | CHUDAKOV | 1 | 1 | D | EUGENE C | 11-006 | 11-026 |  |  | 12-021 | 12-053 |
| 1546415 |  | Test Pair Spectrometer Prototype | 25d | 2012-06-18 | 2012-07-20 | 1546410 | 160d | 0d | ELEC ENG [68 h]; ELEC TECH [68 h] | 7,798.92 | CHUDAKOV | 1 | 1 | D | EUGENE C | 11-006 | 11-026 | 12-054F |  | 12-021 |  |
| 1546370 |  | Test Thermistor Boards | 64d | 2012-06-25 | 2012-09-21 | 1546365a FS-75d, 1546315 | 228d | 0d | ELEC TECH [272 h] | 12,003.36 | CHUDAKOV | 1 | 1 | D | EUGENE C | 11-006 | 11-026 |  |  | 12-021 |  |
| 1546375 |  | Test Transition Boards | 25d | 2012-07-09 | 2012-08-10 | 1546370 FS-54d, 1546320 | 228d | 15d | ELEC TECH [68 h] | 3,000.84 | CHUDAKOV | 1 | 1 | D | EUGENE C | 11-006 | 11-026 |  |  | 12-021 |  |
| 1546420 |  | Pair Spectrometer Production Procurement Prep | 34d | 2012-07-23 | 2012-09-07 | 1546415 | 160d | 0d | ELEC ENG [28 h]; ELEC TECH [68 h] | 4,976.52 | CHUDAKOV | 1 | 1 | D | EUGENE C | 11-006 | 11-026 | 12-054F |  | 12-021 |  |
| 1546445 |  | Pair Spectrometer Power Supplies Procurement Prep | 37d | 2012-07-25 | 2012-09-14 | 1546400, 9-120M FS+200d | 129d | 0d | ELEC ENG [96 h] | 6,773.76 | CHUDAKOV | 1 | 1 | D | EUGENE C | 11-006 | 11-026 |  |  | 12-021 |  |
| 1546425 |  | Procure Pair Spectrometer Readout Board | 25d | 2012-07-30 | 2012-08-31 | 1546420 FS-29d | 215d | 64d | PROCUREMENT<$50K 60 | 5,800 | CHUDAKOV | 1 | 1 | D | EUGENE C | 11-006 | 11-026 |  |  | 12-021 |  |
| 1546330 |  | Procure Coax Cables (Qty.768) | 39d | 2012-08-06 | 2012-09-28 | 1546325 FS-20d | 218d | 5d | PROCUREMENT<$50K 60 | 38,400 | CHUDAKOV | 1 | 1 | D | EUGENE C | 11-006 | 11-026 |  |  | 12-021 |  |
| 1546430 |  | Procure Pair Spectrometer Transition Board | 39d | 2012-08-06 | 2012-09-28 | 1546420 FS-24d | 170d | 0d | PROCUREMENT<$50K 60 | 1,600 | CHUDAKOV | 1 | 1 | D | EUGENE C | 11-006 | 11-026 | 12-054F |  | 12-021 |  |
| 1546435 |  | Procure Pair Spectrometer Power Distribution | 34d | 2012-08-13 | 2012-09-28 | 1546420 FS-19d | 160d | 0d | PROCUREMENT<$50K 60 | 1,050 | CHUDAKOV | 1 | 1 | D | EUGENE C | 11-006 | 11-026 | 12-054F |  | 12-021 |  |
| 1546440 |  | Procure Pair Spectrometer Coax Cables | 72d | 2012-08-20 | 2012-11-30 | 1546420 FS-14d | 195d | 44d | PROCUREMENT<$50K 60 NO ESCALATION FY13 | 10,500 | CHUDAKOV | 1 | 1 | D | EUGENE C | 11-006 | 11-026 |  |  | 12-021 |  |

| ID | Activity | Duration | Start | Finish | Predecessors | Total float | Free float | Calendar | Resources | Cost | RESP - Responsibility | STRT%COMP for CM EVM | FNSH%COMP for CM EVM | HALL D Related Milestones | CAM RESPONSIBLE | CR 11-006 | CR 11-026 | CR 12-021 | CR 12-053 | CR 13-014 | ReBaseline Actuals Adjustment | Original Activity ID Rebaseline | EVMS Reporting Codes | CR 13-007 | BOE Labor | CR 13-015 | Post Rebaseline | Over Under Fixed | BOE Procurement | Obligated Prior to Rebaseline | CR 12-054 | BOE Expenses | CR 14-001 |
| --- | --- | --- | --- | --- | --- | --- | --- | --- | --- | --- | --- | --- | --- | --- | --- | --- | --- | --- | --- | --- | --- | --- | --- | --- | --- | --- | --- | --- | --- | --- | --- | --- | --- |
| 1546380 | Test Power Distribution FY12 | 19d | 2012-09-04 | 2012-09-28 | 1546325, 1546390, 1546375 | 213d | 0d |  | ELEC ENG [62.9 h] | 4,438.22 | CHUDAKOV | 1 | 1 | D | EUGENE C | 11-006 | 11-026 | 12-021 | 12-053 |  |  |  |  |  |  |  |  |  |  |  |  |  |  |
| 1546365a | Test U-Boards FY13 | 6d | 2012-10-01 | 2012-10-08 | 1546365 | 228d | 0d |  | ELEC TECH [38.4 h] | 1,748.74 | CHUDAKOV | 1 | 1 | D | EUGENE C | 11-006 | 11-026 | 12-021 | 12-053 |  |  |  |  |  |  |  |  |  |  |  |  |  |  |
| 1546450 | Procure LV Mod Preamp | 99d | 2012-10-01 | 2013-02-28 | 1546445 FS+10d | 129d | 0d |  | PROCUREMENT<$50K 60 | 7,223.3 | CHUDAKOV | 1 | 1 | D | EUGENE C | 11-006 | 11-026 | 12-021 |  |  |  |  |  |  |  |  |  |  |  |  |  |  |  |
| 1546455 | Procure LV Bias | 99d | 2012-10-01 | 2013-02-28 | 1546445 FS+10d | 129d | 0d |  | PROCUREMENT<$50K 60 | 9,287.1 | CHUDAKOV | 1 | 1 | D | EUGENE C | 11-006 | 11-026 | 12-021 |  |  |  |  |  |  |  |  |  |  |  |  |  |  |  |
| 1546460 | Procure LV Chassis | 99d | 2012-10-01 | 2013-02-28 | 1546445 FS+10d | 129d | 0d |  | PROCUREMENT<$50K 60 | 6,810.54 | CHUDAKOV | 1 | 1 | D | EUGENE C | 11-006 | 11-026 | 12-021 |  |  |  |  |  |  |  |  |  |  |  |  |  |  |  |
| 1546465 | Procure LV Cables | 99d | 2012-10-01 | 2013-02-28 | 1546445 FS+10d | 129d | 0d |  | PROCUREMENT<$50K 60 | 412.76 | CHUDAKOV | 1 | 1 | D | EUGENE C | 11-006 | 11-026 | 12-021 |  |  |  |  |  |  |  |  |  |  |  |  |  |  |  |
| 1546550 | Procure LV Mod Preamp | 99d | 2012-10-01 | 2013-02-28 | 9-130M | 129d | 0d |  | PROCUREMENT<$50K 60 | 7,223.3 | CHUDAKOV | 1 | 1 | D | EUGENE C | 11-006 | 11-026 | 12-021 |  |  |  |  |  |  |  |  |  |  |  |  |  |  |  |
| 1546555 | Procure LV Bias | 99d | 2012-10-01 | 2013-02-28 | 9-130M | 129d | 0d |  | PROCUREMENT<$50K 60 | 9,287.1 | CHUDAKOV | 1 | 1 | D | EUGENE C | 11-006 | 11-026 | 12-021 |  |  |  |  |  |  |  |  |  |  |  |  |  |  |  |
| 1546560 | Procure LV Chassis | 99d | 2012-10-01 | 2013-02-28 | 9-130M | 129d | 0d |  | PROCUREMENT<$50K 60 | 6,810.54 | CHUDAKOV | 1 | 1 | D | EUGENE C | 11-006 | 11-026 | 12-021 |  |  |  |  |  |  |  |  |  |  |  |  |  |  |  |
| 1546565 | Procure LV Cables | 99d | 2012-10-01 | 2013-02-28 | 9-130M | 129d | 0d |  | PROCUREMENT<$50K 60 | 412.76 | CHUDAKOV | 1 | 1 | D | EUGENE C | 11-006 | 11-026 | 12-021 |  |  |  |  |  |  |  |  |  |  |  |  |  |  |  |
| 1546345 | Procure Disc/TDC Cable(Qty.24) | 24d | 2013-01-25 | 2013-02-28 | 9-130M FS+75d | 134d | 0d |  | PROCUREMENT<$50K 60 | 619.14 | CHUDAKOV | 1 | 1 | D | EUGENE C | 11-006 | 11-026 | 12-021 |  |  |  |  |  |  |  |  |  |  |  |  |  |  |  |
| 1546520 | Start Counter Production Procurement Prep | 39d | 2013-02-19 | 2013-04-12 | 1546515, 9-130M FS+91d | 42d | 0d |  | ELEC ENG [96 h] | 6,989.76 | CHUDAKOV | 1 | 1 | D | EUGENE C | 11-006 | 11-026 | 12-021 |  |  |  |  |  |  |  |  |  |  |  |  |  |  |  |
| 1546525 | Procure Start Counter ST Readout Board | 49d | 2013-03-25 | 2013-05-31 | 1546520 FS-15d | 74d | 0d |  | PROCUREMENT<$50K 60 | 5,159.5 | CHUDAKOV | 1 | 1 | D | EUGENE C | 11-006 | 11-026 | 12-021 |  |  |  |  |  |  |  |  |  |  |  |  |  |  |  |
| 1546530 | Procure Start Counter Transition Board | 17d | 2013-04-08 | 2013-04-30 | 1546520 FS-5d | 69d | 0d |  | PROCUREMENT<$50K 60 | 1,651.04 | CHUDAKOV | 1 | 1 | D | EUGENE C | 11-006 | 11-026 | 12-021 |  |  |  |  |  |  |  |  |  |  |  |  |  |  |  |
| 1546535 | Procure Start Counter Power Distribution | 39d | 2013-04-08 | 2013-05-31 | 1546520 FS-5d | 50d | 0d |  | PROCUREMENT<$50K 60 | 1,083.5 | CHUDAKOV | 1 | 1 | D | EUGENE C | 11-006 | 11-026 | 12-021 |  |  |  |  |  |  |  |  |  |  |  |  |  |  |  |
| 1546540 | Procure Start Counter Coax Cables | 81d | 2013-04-08 | 2013-07-31 | 1546520 FS-5d | 42d |  |  | PROCUREMENT<$50K 60 | 1,599.45 | CHUDAKOV | 1 | 1 | D | EUGENE C | 11-006 | 11-026 | 12-021 |  |  |  |  |  |  |  |  |  |  |  |  |  |  |  |
| 1546570 | Re-Baseline Actuals Adjustment | 1d | 2013-08-30 | 2013-08-30 | 9-130M FS+227d | 20d |  |  | PROCUREMENT>$50K 69 NO ESCALATION | -130,660.48 | CHUDAKOV | 1 | 1 |  | EUGENE C |  |  |  |  | 13-014 | ADJ |  |  |  |  |  |  |  |  |  |  |  |  |
| 2546362 | Assemble BCAL Readout V3, Power Dist. & SYST | 20d | 2013-09-03 | 2013-09-30 | 9-130M FS+228d | 179d | 0d | 8/5 M-F w/JLAB Holidays ReBaseline | ELEC TECH [48 h]; ELEC ENG [8 h] | 2,768.4 | CHUDAKOV | 1 | 1 | D | EUGENE C |  |  |  |  |  |  | 2546362 | U | 13-007 | EJ | 13-015 | PR |  |  |  |  |  |  |
| 2546425 | Procure Pair Spectrometer Readout Board | 20d | 2013-09-03 | 2013-09-30 | 9-130M FS+228d | 199d | 0d | 8/5 M-F w/JLAB Holidays ReBaseline | PROCUREMENT<$50K 60 | 3,747.65 | CHUDAKOV | 1 | 1 | D | EUGENE C | 11-006 | 11-026 | 12-021 |  |  |  | 2546425 | D |  |  | 13-015 | PR | y | PE | OB |  |  |  |
| 2546430 | Procure Pair Spectrometer Transition Board | 20d | 2013-09-03 | 2013-09-30 | 9-130M FS+228d | 199d | 0d | 8/5 M-F w/JLAB Holidays ReBaseline | PROCUREMENT<$50K 60 | 3,226 | CHUDAKOV | 1 | 1 | D | EUGENE C | 11-006 | 11-026 | 12-021 |  |  |  | 2546430 | D |  |  | 13-015 | PR | y | PE | OB | 12-054F |  |  |
| 2546435 | Procure Pair Spectrometer Power Distribution | 20d | 2013-09-03 | 2013-09-30 | 9-130M FS+228d | 199d | 0d | 8/5 M-F w/JLAB Holidays ReBaseline | PROCUREMENT<$50K 60 | 3,220 | CHUDAKOV | 1 | 1 | D | EUGENE C | 11-006 | 11-026 | 12-021 |  |  |  | 2546435 | D |  |  | 13-015 | PR | y | PE | OB | 12-054F |  |  |
| 2546465 | Procure LV Cables | 20d | 2013-09-03 | 2013-09-30 | 9-130M FS+228d | 247d |  | 8/5 M-F w/JLAB Holidays ReBaseline | ELEC TECH [8 h]; PROCUREMENT<$50K 60 | 444.32 | CHUDAKOV | 1 | 1 | D | EUGENE C | 11-006 | 11-026 | 12-021 |  |  |  | 2546465 | D |  | PE | 13-015 | PR |  | PE |  |  |  |  |
| 2546565 | Procure LV Cables | 20d | 2013-09-03 | 2013-09-30 | 9-130M FS+228d | 247d |  | 8/5 M-F w/JLAB Holidays ReBaseline | ELEC TECH [4 h]; PROCUREMENT<$50K 60 | 223.44 | CHUDAKOV | 1 | 1 | D | EUGENE C | 11-006 | 11-026 | 12-021 |  |  |  | 2546565 | D |  | PE | 13-015 | PR |  | PE |  |  |  |  |
| 2546567 | Start Counter Integration FY13 | 20d | 2013-09-03 | 2013-09-30 | 9-130M FS+228d | 208d | 0d | 8/5 M-F w/JLAB Holidays ReBaseline | ELEC TECH [29.39 h] | 1,338.42 | CHUDAKOV | 1 | 1 | D | EUGENE C | 11-006 | 11-026 | 12-021 |  |  |  | 2546567 | U |  | PE | 13-015 | PR |  |  |  |  |  |  |
| 2546585 | Tagger Microscope PreAmp Board (37) Procurement | 54d | 2013-09-03 | 2013-11-15 | 9-130M FS+228d | 153d | 86d | 8/5 M-F w/JLAB Holidays ReBaseline | ELEC TECH; PROCUREMENT<$50K 60 NO ESCALATION FY14 | 7,500 | CHUDAKOV | 1 | 1 | D | EUGENE C |  |  |  |  |  |  | 2546585 | U | 13-007 | PE | 13-015 | PR |  | PE |  |  |  |  |
| 2546585a | Tagger Microscope PreAmp Board (37) Labor FY13 | 20d | 2013-09-03 | 2013-09-30 | 9-130M FS+228d | 153d | 0d | 8/5 M-F w/JLAB Holidays ReBaseline | ELEC TECH [44.44 h] | 2,023.8 | CHUDAKOV | 1 | 1 | D | EUGENE C |  |  |  |  |  |  | 2546585 | U | 13-007 | PE | 13-015 | PR |  | PE |  |  |  |  |
| 2546600 | Tagger Hodoscope PreAmp Board (233) (Previously Obligated) | 49d | 2013-09-03 | 2013-11-08 | 9-130M FS+228d | 158d | 91d | 8/5 M-F w/JLAB Holidays ReBaseline | PROCUREMENT<$50K 60 NO ESCALATION FY14 | 12,865 | CHUDAKOV | 1 | 1 | D | EUGENE C |  |  |  |  |  |  | 2546600 | U | 13-007 | PE | 13-015 | PR | y | PE | OB |  |  |  |
| 2546605 | Tagger Hodoscope PreAmp Board (233) - Procurement | 49d | 2013-09-03 | 2013-11-08 | 9-130M FS+228d | 158d | 91d | 8/5 M-F w/JLAB Holidays ReBaseline | PROCUREMENT<$50K 60 NO ESCALATION FY14; ELEC ENG; ELEC TECH | 3,134.92 | CHUDAKOV | 1 | 1 | D | EUGENE C |  |  |  |  |  |  | 2546600 | U | 13-007 | PE | 13-015 | PR |  | PE |  |  |  |  |
| 2546605a | Tagger Hodoscope PreAmp Board (233) - Labor FY13 | 20d | 2013-09-03 | 2013-09-30 | 9-130M FS+228d | 158d | 0d | 8/5 M-F w/JLAB Holidays ReBaseline | ELEC ENG [6.53 h]; ELEC TECH [52.25 h] | 2,854.94 | CHUDAKOV | 1 | 1 | D | EUGENE C |  |  |  |  |  |  | 2546600 | U | 13-007 | PE | 13-015 | PR |  | PE |  |  |  |  |
| 2546610 | BCAL/FCAL Monitoring Distribution Sys. Procurement Support FY13 | 20d | 2013-09-03 | 2013-09-30 | 9-130M FS+228d | 172d | 0d | 8/5 M-F w/JLAB Holidays ReBaseline | ELEC ENG [7.58 h]; ELEC TECH [30.31 h] | 1,932.16 | CHUDAKOV | 1 | 1 | D | EUGENE C |  |  |  |  |  |  | 2546610 | S | 13-007 | PE | 13-015 | PR |  |  |  |  |  |  |
| 2546615 | BCAL/FCAL Monitoring Distribution COTS Electronics | 77d | 2013-09-03 | 2013-12-20 | 9-130M FS+228d | 190d |  | 8/5 M-F w/JLAB Holidays ReBaseline | PROCUREMENT<$50K 60 NO ESCALATION FY14 | 16,134 | CHUDAKOV | 1 | 1 | D | EUGENE C |  |  |  |  |  |  | 2546615 | D | 13-007 |  | 13-015 | PR | y | CP | OB |  |  |  |
| 2546620 | BCAL/FCAL Monitoring Distribution Box (10) - Procurement | 95d | 2013-09-03 | 2014-01-28 | 9-130M FS+228d | 172d |  | 8/5 M-F w/JLAB Holidays ReBaseline | ELEC TECH; PROCUREMENT<$50K 60 NO ESCALATION FY14 | 10,000 | CHUDAKOV | 1 | 1 | D | EUGENE C |  |  |  |  |  |  | 2546620 | S | 13-007 | PE | 13-015 | PR |  | PE |  |  |  |  |
| 2546620a | BCAL/FCAL Monitoring Distribution Box (10) - Labor FY13 | 20d | 2013-09-03 | 2013-09-30 | 9-130M FS+228d | 172d | 0d | 8/5 M-F w/JLAB Holidays ReBaseline | ELEC TECH [42.11 h] | 1,917.69 | CHUDAKOV | 1 | 1 | D | EUGENE C |  |  |  |  |  |  | 2546620 | S | 13-007 | PE | 13-015 | PR |  | PE |  |  |  |  |
| 2546625 | BCAL/FCAL Monitoring Distribution Cables (64+64) (Previously Obligated) | 98d | 2013-09-03 | 2014-01-31 | 9-130M FS+228d | 169d |  | 8/5 M-F w/JLAB Holidays ReBaseline | PROCUREMENT<$50K 60 NO ESCALATION FY14 | 6,012 | CHUDAKOV | 1 | 1 | D | EUGENE C |  |  |  |  |  |  | 2546625 | D | 13-007 |  | 13-015 | PR | y | PE | OB |  |  |  |
| 2546630 | BCAL/FCAL Monitoring Distribution Cables (64+64) | 98d | 2013-09-03 | 2014-01-31 | 9-130M FS+228d | 169d |  | 8/5 M-F w/JLAB Holidays ReBaseline | PROCUREMENT<$50K 60 NO ESCALATION FY14 | 3,588 | CHUDAKOV | 1 | 1 | D | EUGENE C |  |  |  |  |  |  | 2546625 | D | 13-007 |  | 13-015 | PR |  | PE |  |  |  |  |
| 2546640 | Cables Type 1 (TAGH PS PSC COLLI) (350) | 77d | 2013-09-03 | 2013-12-20 | 9-130M FS+228d | 190d |  | 8/5 M-F w/JLAB Holidays ReBaseline | PROCUREMENT<$50K 60 NO ESCALATION FY14; PROCUREMENT>$50K 69 NO ESCALATION | 18,484 | CHUDAKOV | 1 | 1 | D | EUGENE C |  |  |  |  |  |  | 2546640 | D | 13-007 |  | 13-015 | PR | y | PE | OB |  |  |  |
| 2546645 | Splitter Output (TOF TAGM PSC) (630) | 54d | 2013-09-03 | 2013-11-15 | 9-130M FS+228d | 213d |  | 8/5 M-F w/JLAB Holidays ReBaseline | PROCUREMENT<$50K 60 NO ESCALATION FY14 | 31,331 | CHUDAKOV | 1 | 1 | D | EUGENE C |  |  |  |  |  |  | 2546645 | D | 13-007 |  | 13-015 | PR | y | PE | OB |  |  |  |
| 2546650 | Install Hardware, Labels and Tie Wraps FY13 | 20d | 2013-09-03 | 2013-09-30 | 9-130M FS+228d | 0d |  | 8/5 M-F w/JLAB Holidays ReBaseline | SUPPLIES & MATERIALS | 449.44 | CHUDAKOV | 1 | 1 | D | EUGENE C |  |  |  |  |  |  | 2546650 | D | 13-007 |  | 13-015 | PR |  |  |  |  | EJ |  |
| 2546660 | Twisted Pair Cables for TDCs | 77d | 2013-09-03 | 2013-12-20 | 9-130M FS+228d | 100d | 20d | 8/5 M-F w/JLAB Holidays ReBaseline | PROCUREMENT<$50K 60 NO ESCALATION FY14 | 1,908 | CHUDAKOV | 1 | 1 | D | EUGENE C |  |  |  |  |  |  | 2546660 | D | 13-007 |  | 13-015 | PR | y | CP | OB |  |  |  |
| 2546470 | Pair Spectrometer Integration FY13 | 16d | 2013-09-09 | 2013-09-30 | 9-130M FS+232d | 175d | 0d | 8/5 M-F w/JLAB Holidays ReBaseline | ELEC TECH [52.6 h] | 2,395.4 | CHUDAKOV | 1 | 1 | D | EUGENE C | 11-006 | 11-026 | 12-021 |  |  |  | 2546470 | U |  | EJ | 13-015 | PR |  |  |  |  |  |  |
| 2546470a | Pair Spectrometer Integration FY14 | 57d | 2013-10-01 | 2013-12-20 | 2546470, 9-130M FS+232d | 175d | 38d | 8/5 M-F w/JLAB Holidays ReBaseline | ELEC TECH [187.4 h] | 8,805.93 | CHUDAKOV | 1 | 1 | D | EUGENE C | 11-006 | 11-026 | 12-021 |  |  |  | 2546470 | U |  | EJ | 13-015 | PR |  |  |  |  |  | 14-001 |
| 2546567a | Start Counter Integration FY14 | 29d | 2013-10-01 | 2013-11-08 | 9-130M FS+228d, 2546567 | 208d | 197d | 8/5 M-F w/JLAB Holidays ReBaseline | ELEC TECH [42.61 h] | 2,002.24 | CHUDAKOV | 1 | 1 | D | EUGENE C | 11-006 | 11-026 | 12-021 |  |  |  | 2546567 | U |  | PE | 13-015 | PR |  |  |  |  |  | 14-001 |
| 2546585b | Tagger Microscope PreAmp Board (37) Labor FY14 | 34d | 2013-10-01 | 2013-11-15 | 9-130M FS+228d, 2546585a | 153d | 86d | 8/5 M-F w/JLAB Holidays ReBaseline | ELEC TECH [75.56 h] | 3,550.56 | CHUDAKOV | 1 | 1 | D | EUGENE C |  |  |  |  |  |  | 2546585 | U | 13-007 | PE | 13-015 | PR |  | PE |  |  |  | 14-001 |
| 2546605b | Tagger Hodoscope PreAmp Board (233) - Labor FY14 | 29d | 2013-10-01 | 2013-11-08 | 9-130M FS+228d, 2546605a | 158d | 91d | 8/5 M-F w/JLAB Holidays ReBaseline | ELEC ENG [9.47 h]; ELEC TECH [75.75 h] | 4,270.94 | CHUDAKOV | 1 | 1 | D | EUGENE C |  |  |  |  |  |  | 2546600 | U | 13-007 | PE | 13-015 | PR |  | PE |  |  |  | 14-001 |
| 2546610a | BCAL/FCAL Monitoring Distribution Sys. Procurement Support FY14 | 75d | 2013-10-01 | 2014-01-28 | 2546610, 9-130M FS+228d | 172d |  | 8/5 M-F w/JLAB Holidays ReBaseline | ELEC ENG [28.42 h]; ELEC TECH [113.69 h] | 7,477.54 | CHUDAKOV | 1 | 1 | D | EUGENE C |  |  |  |  |  |  | 2546610 | S | 13-007 | PE | 13-015 | PR |  |  |  |  |  | 14-001 |
| 2546620b | BCAL/FCAL Monitoring Distribution Box (10) - Labor FY4 | 75d | 2013-10-01 | 2014-01-28 | 9-130M FS+228d, 2546620a | 172d |  | 8/5 M-F w/JLAB Holidays ReBaseline | ELEC TECH [157.89 h] | 7,419.25 | CHUDAKOV | 1 | 1 | D | EUGENE C |  |  |  |  |  |  | 2546620 | S | 13-007 | PE | 13-015 | PR |  | PE |  |  |  | 14-001 |
| 2546650a | Install Hardware, Labels and Tie Wraps FY14 | 247d | 2013-10-01 | 2014-09-30 | 9-130M FS+228d, 2546650 | 0d |  | 8/5 M-F w/JLAB Holidays ReBaseline | SUPPLIES & MATERIALS | 5,727.62 | CHUDAKOV | 1 | 1 | D | EUGENE C |  |  |  |  |  |  | 2546650 | D | 13-007 |  | 13-015 | PR |  |  |  |  | EJ | 14-001 |
| 2546655 | Splitters Parts Boards and Assembly (10) | 139d | 2013-11-08 | 2014-06-06 | 9-140M FS+28d | 80d |  | 8/5 M-F w/JLAB Holidays ReBaseline | ELEC TECH [150 h]; PROCUREMENT<$50K 60 | 20,979.15 | CHUDAKOV | 1 | 1 | D | EUGENE C |  |  |  |  |  |  | 2546655 | D | 13-007 | PE | 13-015 | PR |  | EJ |  |  |  | 14-001 |

| ID | WBS | Activity | Duration | Start | Finish | Predecessors | Total float | Free float | Calendar | Resources | Cost | RESP - Responsibility | STRT%COMP for CM EVM | FNSH%COMP for CM EVM | HALL D Related Milestones | CAM RESPONSIBLE | CR 11-006 | CR 11-026 | CR 12-054 | CR 12-001 | CR 12-021 | CR 13-014 | ReBaseline Actuals Adjustment | Original Activity ID Rebaseline | EVMS Reporting Codes | CR 13-007 | BOE Labor | CR 13-015 | Post Rebaseline | CR 14-001 |
| --- | --- | --- | --- | --- | --- | --- | --- | --- | --- | --- | --- | --- | --- | --- | --- | --- | --- | --- | --- | --- | --- | --- | --- | --- | --- | --- | --- | --- | --- | --- |
|  | 7 | **1.5.4.7 DETECTOR CABLING** |  | 2011-01-11 | 2014-01-31 |  |  |  |  |  |  |  |  |  |  |  |  |  |  |  |  |  |  |  |  |  |  |  |  |  |
| 1547005 |  | Cables - Low Voltage Cabling Development (FDC&CDC) | 52d | 2011-01-11 | 2011-03-25 | 9-110M FS+64d | 337d | 0d |  | ELEC ENG [80 h]; ELEC TECH [80 h] | 8,892 | CHUDAKOV | 1 | 1 | D | EUGENE C | 11-006 | 11-026 | 12-054F |  |  |  |  |  |  |  |  |  |  |  |
| 1547010 |  | Cables - Low Voltage Cabling Procurement Support (FDC&CDC) | 108d | 2011-03-28 | 2011-08-26 | 1547005 | 337d | 0d |  | ELEC ENG [240 h] | 16,411.2 | CHUDAKOV | 1 | 1 | D | EUGENE C | 11-006 | 11-026 | 12-054F |  |  |  |  |  |  |  |  |  |  |  |
| 1547020 |  | Cables - Low Voltage Distribution Development (FDC&CDC) | 93d | 2011-03-28 | 2011-08-05 | 1547005 | 340d | 0d |  | ELEC ENG [80 h]; ELEC TECH [320 h] | 19,156.8 | CHUDAKOV | 1 | 1 | D | EUGENE C | 11-006 | 11-026 | 12-054F |  |  |  |  |  |  |  |  |  |  |  |
| 1547025 |  | Cables - Low Voltage Distribution Chassis (FDC&CDC) | 93d | 2011-04-18 | 2011-08-26 | 1547020 FS-78d | 340d | 0d |  | PROCUREMENT<$50K 60 | 21,000 | CHUDAKOV | 1 | 1 | D | EUGENE C | 11-006 | 11-026 | 12-054F |  |  |  |  |  |  |  |  |  |  |  |
| 1547035 |  | Cables - Coax Signal Procurement Support FY11 | 61d | 2011-07-07 | 2011-09-30 | 9-110M FS+187d | 36d | 0d |  | ELEC ENG [85.61 h]; ELEC TECH [85.61 h] | 9,515.55 | CHUDAKOV | 1 | 1 | D | EUGENE C | 11-006 | 11-026 | 12-054F | 12-001 | 12-021F |  |  |  |  |  |  |  |  |  |
| 1547040 |  | Cables - Coax HV Procurement Support FY11 | 61d | 2011-07-07 | 2011-09-30 | 9-110M FS+187d | 123d | 0d |  | ELEC ENG [85.61 h]; ELEC TECH [85.61 h] | 9,515.55 | CHUDAKOV | 1 | 1 | D | EUGENE C | 11-006 | 11-026 | 12-054F | 12-001 | 12-021F |  |  |  |  |  |  |  |  |  |
| 1547015 |  | Cables - Low Voltage Assemblies (FDC&CDC) | 80d | 2011-08-29 | 2011-12-21 | 1547010 | 337d | 273d |  | PROCUREMENT<$50K 60 NO ESCALATION FY12 | 45,000 | CHUDAKOV | 1 | 1 | D | EUGENE C | 11-006 | 11-026 | 12-054F |  |  |  |  |  |  |  |  |  |  |  |
| 1547030 |  | Cables - Low Voltage Distribution Supply Cables (FDC&CDC) | 77d | 2011-08-29 | 2011-12-16 | 1547025 | 340d | 276d |  | PROCUREMENT<$50K 60 NO ESCALATION FY12 | 10,000 | CHUDAKOV | 1 | 1 | D | EUGENE C | 11-006 | 11-026 | 12-054F |  |  |  |  |  |  |  |  |  |  |  |
| 1547035a |  | Cables - Coax Signal Procurement Support FY12 | 53d | 2011-10-03 | 2011-12-16 | 1547035 | 36d | 0d |  | ELEC ENG [74.39 h]; ELEC TECH [74.39 h] | 8,531.79 | CHUDAKOV | 1 | 1 | D | EUGENE C | 11-006 | 11-026 | 12-054F | 12-001 | 12-021F |  |  |  |  |  |  |  |  |  |
| 1547040a |  | Cables - Coax HV Procurement Support FY12 | 53d | 2011-10-03 | 2011-12-16 | 1547040 | 123d | 0d |  | ELEC ENG [74.39 h]; ELEC TECH [74.39 h] | 8,531.79 | CHUDAKOV | 1 | 1 | D | EUGENE C | 11-006 | 11-026 | 12-054F | 12-001 | 12-021F |  |  |  |  |  |  |  |  |  |
| 1547055 |  | Cables - Coax HV Tagger/Hodoscope | 189d | 2012-01-03 | 2012-09-28 | 1547050 FS-55d | 230d | 60d |  | PROCUREMENT<$50K 60 | 14,704.58 | CHUDAKOV | 1 | 1 | D | EUGENE C | 11-006 | 11-026 |  |  | 12-021 |  |  |  |  |  |  |  |  |  |
| 1547060 |  | Cables - Coax Signal Tagger/Hodoscope | 189d | 2012-01-03 | 2012-09-28 | 1547045 FS-55d | 210d | 60d |  | PROCUREMENT<$50K 60 | 15,994.45 | CHUDAKOV | 1 | 1 | D | EUGENE C | 11-006 | 11-026 | 12-054F |  | 12-021 |  |  |  |  |  |  |  |  |  |
| 1547065 |  | Cables - Coax HV Pair Spectrometer | 189d | 2012-01-03 | 2012-09-28 | 1547050 FS-55d | 220d | 42d |  | PROCUREMENT<$50K 60 | 3,869.63 | CHUDAKOV | 1 | 1 | D | EUGENE C | 11-006 | 11-026 |  |  | 12-021 |  |  |  |  |  |  |  |  |  |
| 1547070 |  | Cables - Coax Signal Pair Spectrometer | 189d | 2012-01-03 | 2012-09-28 | 1547045 FS-55d | 175d | 0d |  | PROCUREMENT<$50K 60 | 2,579.75 | CHUDAKOV | 1 | 1 | D | EUGENE C | 11-006 | 11-026 |  |  | 12-021 |  |  |  |  |  |  |  |  |  |
| 1547075 |  | Cables - Coax HV Start Counter | 189d | 2012-01-03 | 2012-09-28 | 1547050 FS-55d | 123d | 27d |  | PROCUREMENT<$50K 60 | 3,095.7 | CHUDAKOV | 1 | 1 | D | EUGENE C | 11-006 | 11-026 | 12-054F |  | 12-021 |  |  |  |  |  |  |  |  |  |
| 1547080 |  | Cables - Coax Signal Start Counter | 189d | 2012-01-03 | 2012-09-28 | 1547045 FS-55d | 36d | 0d |  | PROCUREMENT<$50K 60 | 2,063.8 | CHUDAKOV | 1 | 1 | D | EUGENE C | 11-006 | 11-026 | 12-054F |  | 12-021 |  |  |  |  |  |  |  |  |  |
| 1547085 |  | Cables - LV BCAL | 189d | 2012-01-03 | 2012-09-28 | 1547050 FS-55d | 220d | 122d |  | PROCUREMENT<$50K 60 | 3,714.84 | CHUDAKOV | 1 | 1 | D | EUGENE C | 11-006 | 11-026 | 12-054F |  | 12-021 |  |  |  |  |  |  |  |  |  |
| 1547090 |  | Cables - Bias BCAL | 189d | 2012-01-03 | 2012-09-28 | 1547045 FS-55d | 228d | 130d |  | PROCUREMENT<$50K 60 | 5,572.26 | CHUDAKOV | 1 | 1 | D | EUGENE C | 11-006 | 11-026 | 12-054F |  | 12-021 |  |  |  |  |  |  |  |  |  |
| 1547095 |  | Cables - Coax Signal BCAL | 189d | 2012-01-03 | 2012-09-28 | 1547045 FS-55d | 80d | 60d |  | PROCUREMENT<$50K 60; PROCUREMENT>$50K 69 | 99,062.4 | CHUDAKOV | 1 | 1 | D | EUGENE C | 11-006 | 11-026 | 12-054F |  | 12-021 |  |  |  |  |  |  |  |  |  |
| 1547100 |  | Cables - Coax HV TOF | 189d | 2012-01-03 | 2012-09-28 | 1547050 FS-55d | 229d | 90d |  | PROCUREMENT<$50K 60 | 13,001.94 | CHUDAKOV | 1 | 1 | D | EUGENE C | 11-006 | 11-026 | 12-054F |  | 12-021 |  |  |  |  |  |  |  |  |  |
| 1547105 |  | Cables - Coax Signal TOF | 189d | 2012-01-03 | 2012-09-28 | 1547045 FS-55d | 228d | 78d |  | PROCUREMENT<$50K 60 | 8,667.96 | CHUDAKOV | 1 | 1 | D | EUGENE C | 11-006 | 11-026 | 12-054F |  | 12-021 |  |  |  |  |  |  |  |  |  |
| 1547110 |  | Cables - Coax Signal FCAL | 189d | 2012-01-03 | 2012-09-28 | 1547045 FS-55d | 127d | 60d |  | PROCUREMENT<$50K 60; PROCUREMENT>$50K 69 | 56,754.5 | CHUDAKOV | 1 | 1 | D | EUGENE C | 11-006 | 11-026 | 12-054F |  | 12-021 |  |  |  |  |  |  |  |  |  |
| 1547045 |  | Cables - Coax Signal Acceptance Tests | 50d | 2012-01-10 | 2012-03-21 | 1547035a FS+10d | 36d | 0d |  | ELEC TECH [240 h] | 10,591.2 | CHUDAKOV | 1 | 1 | D | EUGENE C | 11-006 | 11-026 | 12-054F |  | 12-021F |  |  |  |  |  |  |  |  |  |
| 1547050 |  | Cables - Coax HV Acceptance Tests | 50d | 2012-01-10 | 2012-03-21 | 1547040a FS+10d | 123d | 0d |  | ELEC TECH [240 h] | 10,591.2 | CHUDAKOV | 1 | 1 | D | EUGENE C | 11-006 | 11-026 | 12-054F |  | 12-021F |  |  |  |  |  |  |  |  |  |
| 1547115 |  | Cables - HV Label and Bundle Tagger/Hodoscope | 18d | 2013-01-03 | 2013-01-29 | 1547055, 9-130M FS+60d | 170d |  |  | ELEC TECH [80 h] | 3,643.2 | CHUDAKOV | 1 | 1 | D | EUGENE C | 11-006 | 11-026 | 12-054 |  | 12-021 |  |  |  |  |  |  |  |  |  |
| 1547120 |  | Cables - Signal Label and Bundle Tagger/Hodoscope | 18d | 2013-01-03 | 2013-01-29 | 1547060, 9-130M FS+60d | 150d | 0d |  | ELEC TECH [80 h] | 3,643.2 | CHUDAKOV | 1 | 1 | D | EUGENE C | 11-006 | 11-026 | 12-054 |  | 12-021 |  |  |  |  |  |  |  |  |  |
| 1547125 |  | Cables - HV Label and Bundle Pair Spectrometer | 10d | 2013-01-03 | 2013-01-16 | 9-130M FS+60d, 1547065 FS+18d | 178d |  |  | ELEC TECH [40 h] | 1,821.6 | CHUDAKOV | 1 | 1 | D | EUGENE C | 11-006 | 11-026 | 12-054 |  | 12-021 |  |  |  |  |  |  |  |  |  |
| 1547135 |  | Cables - HV Label and Bundle Start Counter | 10d | 2013-01-03 | 2013-01-16 | 9-130M FS+60d, 1547075 FS+33d | 96d | 0d |  | ELEC TECH [40 h] | 1,821.6 | CHUDAKOV | 1 | 1 | D | EUGENE C | 11-006 | 11-026 | 12-054 |  | 12-021 |  |  |  |  |  |  |  |  |  |
| 1547185 |  | Cables - Signal Label and Bundle BCAL | 150d | 2013-01-03 | 2013-08-06 | 1547095, 9-130M FS+60d | 20d | 0d |  | ELEC TECH [640 h] | 29,145.6 | CHUDAKOV | 1 | 1 | D | EUGENE C | 11-006 | 11-026 | 12-054 |  | 12-021 |  |  |  |  |  |  |  |  |  |
| 1547200 |  | Cables - Signal Label and Bundle FCAL | 97d | 2013-01-03 | 2013-05-21 | 1547110, 9-130M FS+60d | 67d | 47d |  | ELEC TECH [400 h] | 18,216 | CHUDAKOV | 1 | 1 | D | EUGENE C | 11-006 | 11-026 | 12-054 |  | 12-021 |  |  |  |  |  |  |  |  |  |
| 1547130 |  | Cables - Signal Label and Bundle Pair Spectrometer | 10d | 2013-01-08 | 2013-01-22 | 1547070 FS+63d, 9-130M FS+60d | 175d |  |  | ELEC TECH [40 h] | 1,821.6 | CHUDAKOV | 1 | 1 | D | EUGENE C | 11-006 | 11-026 |  |  | 12-021 |  |  |  |  |  |  |  |  |  |
| 1547150 |  | Cables - HV Label and Bundle CDC | 10d | 2013-01-17 | 2013-01-31 | 9-130M FS+60d, 1547135 | 96d | 0d |  | ELEC TECH [40 h] | 1,821.6 | CHUDAKOV | 1 | 1 | D | EUGENE C | 11-006 | 11-026 | 12-054 |  | 12-021 |  |  |  |  |  |  |  |  |  |
| 1547140 |  | Cables - Signal Label and Bundle Start Counter | 9d | 2013-01-23 | 2013-02-04 | 1547080 FS+73d, 9-130M FS+60d | 36d | 0d |  | ELEC TECH [40 h] | 1,821.6 | CHUDAKOV | 1 | 1 | D | EUGENE C | 11-006 | 11-026 | 12-054 |  | 12-021 |  |  |  |  |  |  |  |  |  |
| 1547195 |  | Cables - Signal Label and Bundle TOF | 20d | 2013-01-30 | 2013-02-27 | 1547105, 1547120, 9-130M FS+60d | 150d |  |  | ELEC TECH [80 h] | 3,643.2 | CHUDAKOV | 1 | 1 | D | EUGENE C | 11-006 | 11-026 | 12-054 |  | 12-021 |  |  |  |  |  |  |  |  |  |
| 1547165 |  | Cables - HV Label and Bundle FDC | 10d | 2013-02-01 | 2013-02-14 | 1547150, 9-130M FS+60d | 96d | 0d |  | ELEC TECH [40 h] | 1,821.6 | CHUDAKOV | 1 | 1 | D | EUGENE C | 11-006 | 11-026 | 12-054 |  | 12-021 |  |  |  |  |  |  |  |  |  |
| 1547145 |  | Cables - LV Label and Bundle CDC | 10d | 2013-02-05 | 2013-02-19 | 1547030, 1547015, 1547140, 9-130M FS+60d | 64d | 0d |  | ELEC TECH [40 h] | 1,821.6 | CHUDAKOV | 1 | 1 | D | EUGENE C | 11-006 | 11-026 | 12-054 |  | 12-021 |  |  |  |  |  |  |  |  |  |
| 1547155 |  | Cables - Signal Label and Bundle CDC | 20d | 2013-02-05 | 2013-03-05 | 1547140, 9-130M FS+60d | 36d | 0d |  | ELEC TECH [80 h] | 3,643.2 | CHUDAKOV | 1 | 1 | D | EUGENE C | 11-006 | 11-026 | 12-054F |  | 12-021 |  |  |  |  |  |  |  |  |  |
| 1547190 |  | Cables - HV Label and Bundle TOF | 19d | 2013-02-15 | 2013-03-14 | 9-130M FS+60d, 1547100, 1547165 | 139d |  |  | ELEC TECH [80 h] | 3,643.2 | CHUDAKOV | 1 | 1 | D | EUGENE C | 11-006 | 11-026 | 12-054 |  | 12-021 |  |  |  |  |  |  |  |  |  |
| 1547160 |  | Cables - LV Label and Bundle FDC | 30d | 2013-02-20 | 2013-04-02 | 9-130M FS+60d, 1547145 | 64d | 0d |  | ELEC TECH [120 h] | 5,464.8 | CHUDAKOV | 1 | 1 | D | EUGENE C | 11-006 | 11-026 | 12-054F |  | 12-021 |  |  |  |  |  |  |  |  |  |
| 1547170 |  | Cables - Signal Label and Bundle FDC | 48d | 2013-03-06 | 2013-05-10 | 1547155, 9-130M FS+60d | 36d | 16d |  | ELEC TECH [200 h] | 9,108 | CHUDAKOV | 1 | 1 | D | EUGENE C | 11-006 | 11-026 | 12-054F |  | 12-021 |  |  |  |  |  |  |  |  |  |
| 1547175 |  | Cables - LV Label and Bundle BCAL | 8d | 2013-04-03 | 2013-04-12 | 1547160, 9-130M FS+60d, 1547085 | 98d | 0d |  | ELEC TECH [40 h] | 1,821.6 | CHUDAKOV | 1 | 1 | D | EUGENE C | 11-006 | 11-026 | 12-054F |  | 12-021 |  |  |  |  |  |  |  |  |  |
| 1547180 |  | Cables - Bias Label and Bundle BCAL | 10d | 2013-04-15 | 2013-04-26 | 9-130M FS+60d, 1547175, 1547090 | 98d | 78d |  | ELEC TECH [40 h] | 1,821.6 | CHUDAKOV | 1 | 1 | D | EUGENE C | 11-006 | 11-026 | 12-054F |  | 12-021 |  |  |  |  |  |  |  |  |  |
| 1547205 |  | Re-Baseline Actuals Adjustment | 1d | 2013-08-30 | 2013-08-30 | 9-130M FS+227d | 20d |  |  | PROCUREMENT>$50K 69 NO ESCALATION | -102,247.05 | CHUDAKOV | 1 | 1 |  | EUGENE C |  |  |  |  |  | 13-014 | ADJ |  |  |  |  |  |  |  |
| 2547170 |  | Cables - Signal Label and Bundle FDC (528) FY13 | 20d | 2013-09-03 | 2013-09-30 | 9-130M FS+228d | 5d | 0d | 8/5 M-F w/JLAB Holidays ReBaseline | ELEC TECH [51.28 h] | 2,335.29 | CHUDAKOV | 1 | 1 | D | EUGENE C | 11-006 | 11-026 | 12-054F |  | 12-021 |  |  | 2547170 | U | 13-007 | PE | 13-015 | PR |  |
| 2547175 |  | Cables - LV Label and Bundle BCAL (24) | 20d | 2013-09-03 | 2013-09-30 | 9-130M FS+228d | 58d | 0d | 8/5 M-F w/JLAB Holidays ReBaseline | ELEC TECH [28 h] | 1,275.12 | CHUDAKOV | 1 | 1 | D | EUGENE C | 11-006 | 11-026 | 12-054F |  | 12-021 |  |  | 2547175 | U | 13-007F | PE | 13-015 | PR |  |
| 2547180 |  | Cables - Bias Label and Bundle BCAL (36) | 20d | 2013-09-03 | 2013-09-30 | 2547175 FS-20d | 58d | 0d | 8/5 M-F w/JLAB Holidays ReBaseline | ELEC TECH [22 h] | 1,001.88 | CHUDAKOV | 1 | 1 | D | EUGENE C | 11-006 | 11-026 | 12-054F |  | 12-021 |  |  | 2547180 | U | 13-007F | PE | 13-015 | PR |  |
| 2547190 |  | Cables - HV Label and Bundle TOF (168) FY13 | 20d | 2013-09-03 | 2013-09-30 | 2547165 FS-25d, 2547165a FS-25d | 127d | 0d | 8/5 M-F w/JLAB Holidays ReBaseline | ELEC TECH [6.53 h] | 297.38 | CHUDAKOV | 1 | 1 | D | EUGENE C | 11-006 | 11-026 | 12-054 |  | 12-021 |  |  | 2547190 | U | 13-007 | PE | 13-015 | PR |  |
| 2547200 |  | Cables - Signal Label and Bundle TOF (168) FY13 | 20d | 2013-09-03 | 2013-09-30 | 2547190 FS-98d, 2547190a FS-98d | 127d | 0d | 8/5 M-F w/JLAB Holidays ReBaseline | ELEC TECH [6.53 h] | 297.38 | CHUDAKOV | 1 | 1 | D | EUGENE C | 11-006 | 11-026 | 12-054 |  | 12-021 |  |  | 2547200 | U | 13-007 | PE | 13-015 | PR |  |
| 2547165 |  | Cables - HV Label and Bundle FDC (8) FY13 | 11d | 2013-09-16 | 2013-09-30 | 9-130M FS+237d | 19d | 0d | 8/5 M-F w/JLAB Holidays ReBaseline | ELEC TECH [27.5 h] | 1,252.35 | CHUDAKOV | 1 | 1 | D | EUGENE C | 11-006 | 11-026 | 12-054 |  | 12-021 |  |  | 2547165 | U | 13-007 | PE | 13-015 | PR |  |
| 2547135 |  | Cables - HV Label and Bundle CDC (6) | 25d | 2013-10-01 | 2013-11-04 | 9-140M | 134d | 0d | 8/5 M-F w/JLAB Holidays ReBaseline | ELEC TECH [40 h] | 1,879.6 | CHUDAKOV | 1 | 1 | D | EUGENE C | 11-006 | 11-026 | 12-054 |  | 12-021 |  |  | 2547135 | U | 13-007 | PE | 13-015 | PR | 14-001 |
| 2547165a |  | Cables - HV Label and Bundle FDC (8) FY14 | 5d | 2013-10-01 | 2013-10-07 | 2547165, 9-130M FS+237d | 19d | 0d | 8/5 M-F w/JLAB Holidays ReBaseline | ELEC TECH [12.5 h] | 587.38 | CHUDAKOV | 1 | 1 | D | EUGENE C | 11-006 | 11-026 | 12-054 |  | 12-021 |  |  | 2547165 | U | 13-007 | PE | 13-015 | PR | 14-001 |
| 2547170a |  | Cables - Signal Label and Bundle FDC (528) FY14 | 19d | 2013-10-01 | 2013-10-25 | 9-130M FS+228d, 2547170 | 5d |  | 8/5 M-F w/JLAB Holidays ReBaseline | ELEC TECH [48.72 h] | 2,289.35 | CHUDAKOV | 1 | 1 | D | EUGENE C | 11-006 | 11-026 | 12-054F |  | 12-021 |  |  | 2547170 | U | 13-007 | PE | 13-015 | PR | 14-001 |
| 2547190a |  | Cables - HV Label and Bundle TOF (168) FY14 | 78d | 2013-10-01 | 2014-01-31 | 2547165a FS-25d, 2547190, 2547165 FS-25d | 127d | 0d | 8/5 M-F w/JLAB Holidays ReBaseline | ELEC TECH [25.47 h] | 1,196.84 | CHUDAKOV | 1 | 1 | D | EUGENE C | 11-006 | 11-026 | 12-054 |  | 12-021 |  |  | 2547190 | U | 13-007 | PE | 13-015 | PR | 14-001 |
| 2547200a |  | Cables - Signal Label and Bundle TOF (168) FY14 | 78d | 2013-10-01 | 2014-01-31 | 2547190 FS-98d, 2547200, 2547190a FS-98d | 127d | 63d | 8/5 M-F w/JLAB Holidays ReBaseline | ELEC TECH [25.47 h] | 1,196.84 | CHUDAKOV | 1 | 1 | D | EUGENE C | 11-006 | 11-026 | 12-054 |  | 12-021 |  |  | 2547200 | U | 13-007 | PE | 13-015 | PR | 14-001 |

| ID | WBS | Activity | Duration | Start | Finish | Predecessors | Total float | Free float | Calendar | Resources | Cost | RESP - Responsibility | STRT%COMP for CM EVM | FNSH%COMP for CM EVM | HALL D Related Milestones | CAM RESPONSIBLE | CR 11-006 | CR 11-026 | CR 11-029 | CR 12-016 | CR 12-021 | CR 12-047 | CR 13-014 | ReBaseline Actuals Adjustment | Original Activity ID Rebaseline | EVMS Reporting Codes | CR 11-049 | CR 12-054 | BOE Labor | CR 13-015 | Post Rebaseline | CR 12-044 | CR 14-001 | Advance Purchase Plan > 500K | CR 08-016 | 12 GEV MAJOR PROCUREMENT CATAGORY | CR 09-014 | CR 11-004 | 12 GeV 2nd level Critical Path | CR 07-024 | CR 09-027 | CR 09-027 Repair | CR 11-030 | CR 10-024 | CR 12-053 | BOE Expenses |
| --- | --- | --- | --- | --- | --- | --- | --- | --- | --- | --- | --- | --- | --- | --- | --- | --- | --- | --- | --- | --- | --- | --- | --- | --- | --- | --- | --- | --- | --- | --- | --- | --- | --- | --- | --- | --- | --- | --- | --- | --- | --- | --- | --- | --- | --- | --- |
|  | 8 | **1.5.4.8 FULL CRATE CHECKS** |  | 2012-06-06 | 2013-12-20 |  |  |  |  |  |  |  |  |  |  |  |  |  |  |  |  |  |  |  |  |  |  |  |  |  |  |  |  |  |  |  |  |  |  |  |  |  |  |  |  |  |
| 1548030 |  | Full Crate Check - Pre Installation,Lab,Install Mods,Test,Log&Label High Voltage | 20d | 2012-06-06 | 2012-07-03 | 1545080, 1545085 | 310d |  |  | ELEC TECH [80 h]; ELEC ENG [20 h] | 4,941.6 | CHUDAKOV | 1 | 1 | D | EUGENE C | 11-006 | 11-026 | 11-029 |  |  |  |  |  |  |  |  |  |  |  |  |  |  |  |  |  |  |  |  |  |  |  |  |  |  |  |
| 1548010 |  | Full Crate Check - Pre Installation,Lab,Install Mods,Test,Log&Label VME64x Discriminator | 15d | 2013-03-01 | 2013-03-21 | 1545028, 1544040, 1546345, 1545030a, 1544025 | 134d |  |  | ELEC ENG [20 h]; ELEC TECH [80 h] | 5,099.4 | CHUDAKOV | 1 | 1 | D | EUGENE C | 11-006 | 11-026 |  | 12-016 | 12-021 |  |  |  |  |  |  |  |  |  |  |  |  |  |  |  |  |  |  |  |  |  |  |  |  |  |
| 1548035 |  | Full Crate Check - Pre Installation,Lab,Install Mods,Test,Log&Label Low Voltage | 20d | 2013-03-01 | 2013-03-28 | 1546555, 1546565, 1546560, 1546450, 1546460, 1545120a, 1546465, 1546550, 1545125a, 1546455, 1545125 | 129d |  |  | ELEC TECH [80 h]; ELEC ENG [20 h] | 5,099.4 | CHUDAKOV | 1 | 1 | D | EUGENE C | 11-006 | 11-026 |  |  | 12-021 |  |  |  |  |  |  |  |  |  |  |  |  |  |  |  |  |  |  |  |  |  |  |  |  |  |
| 1548015 |  | Full Crate Check - Pre Installation,Lab,Install Mods,Test,Log&Label VXS fADC250 | 15d | 2013-04-01 | 2013-04-19 | 1541059, 1544015 | 113d |  |  | ELEC TECH [200 h]; ELEC ENG [20 h] | 10,564.2 | CHUDAKOV | 1 | 1 | D | EUGENE C | 11-006 | 11-026 |  |  |  | 12-047 |  |  |  |  |  |  |  |  |  |  |  |  |  |  |  |  |  |  |  |  |  |  |  |  |
| 1548040 |  | Re-Baseline Actuals Adjustment | 1d | 2013-08-30 | 2013-08-30 | 9-130M FS+227d | 20d |  |  | PROCUREMENT>$50K 69 NO ESCALATION | -12,809.88 | CHUDAKOV | 1 | 1 |  | EUGENE C |  |  |  |  |  |  | 13-014 | ADJ |  |  |  |  |  |  |  |  |  |  |  |  |  |  |  |  |  |  |  |  |  |  |
| 2548025 |  | Full Crate Check - Pre Installation,Lab,Install Mods,Test,Log&Label VXS F1TDC FY13 | 16d | 2013-09-09 | 2013-09-30 | 9-130M FS+232d | 120d | 0d | 8/5 M-F w/JLAB Holidays ReBaseline | ELEC TECH [9.41 h]; ELEC ENG [9.41 h] | 1,113.67 | CHUDAKOV | 1 | 1 | D | EUGENE C | 11-006 | 11-026 |  |  | 12-021 |  |  |  | 2548025 | U | 11-049 | 12-054 | PE | 13-015 | PR |  |  |  |  |  |  |  |  |  |  |  |  |  |  |  |
| 2548020 |  | Full Crate Check - Pre Installation,Lab,Install Mods,Test,Log&Label VXS fADC125 FY13 | 11d | 2013-09-16 | 2013-09-30 | 2541145 FS-88d, 2541145a FS-88d, 2541120a FS-68d, 2541120 FS-68d | 111d | 0d | 8/5 M-F w/JLAB Holidays ReBaseline | ELEC TECH [6.47 h]; ELEC ENG [6.47 h] | 765.72 | CHUDAKOV | 1 | 1 | D | EUGENE C | 11-006 | 11-026 |  |  | 12-021 |  |  |  | 2548020 | U |  | 12-054 | PE | 13-015 | PR | 12-044 |  |  |  |  |  |  |  |  |  |  |  |  |  |  |
| 2548020a |  | Full Crate Check - Pre Installation,Lab,Install Mods,Test,Log&Label VXS fADC125 FY14 | 57d | 2013-10-01 | 2013-12-20 | 2541145a FS-88d, 2541120 FS-68d, 2548020, 2541145 FS-88d, 2541120a FS-68d | 111d | 0d | 8/5 M-F w/JLAB Holidays ReBaseline | ELEC TECH [33.53 h]; ELEC ENG [33.53 h] | 4,094.68 | CHUDAKOV | 1 | 1 | D | EUGENE C | 11-006 | 11-026 |  |  | 12-021 |  |  |  | 2548020 | U |  | 12-054 | PE | 13-015 | PR | 12-044 | 14-001 |  |  |  |  |  |  |  |  |  |  |  |  |  |
| 2548025a |  | Full Crate Check - Pre Installation,Lab,Install Mods,Test,Log&Label VXS F1TDC FY14 | 52d | 2013-10-01 | 2013-12-13 | 2548025, 9-130M FS+232d | 120d | 0d | 8/5 M-F w/JLAB Holidays ReBaseline | ELEC ENG [30.59 h]; ELEC TECH [30.59 h] | 3,735.65 | CHUDAKOV | 1 | 1 | D | EUGENE C | 11-006 | 11-026 |  |  | 12-021 |  |  |  | 2548025 | U | 11-049 | 12-054 | PE | 13-015 | PR |  | 14-001 |  |  |  |  |  |  |  |  |  |  |  |  |  |
|  | 5 | **1.5.5 BEAMLINE** |  | 2009-04-01 | 2015-04-01 |  |  |  |  |  |  |  |  |  |  |  |  |  |  |  |  |  |  |  |  |  |  |  |  |  |  |  |  |  |  |  |  |  |  |  |  |  |  |  |  |  |
|  | 1 | **1.5.5.1 TAGGER** |  | 2009-04-01 | 2014-04-01 |  |  |  |  |  |  |  |  |  |  |  |  |  |  |  |  |  |  |  |  |  |  |  |  |  |  |  |  |  |  |  |  |  |  |  |  |  |  |  |  |  |
|  | 1 | **1.5.5.1.1 TAGGING MAGNET** |  | 2009-04-01 | 2013-10-15 |  |  |  |  |  |  |  |  |  |  |  |  |  |  |  |  |  |  |  |  |  |  |  |  |  |  |  |  |  |  |  |  |  |  |  |  |  |  |  |  |  |
| 15511070 |  | Proc Quad (TAGGING Mag) | 75d | 2009-04-01 | 2009-07-16 | 9-090M FS+120d | 1118d | 694d |  | PROCUREMENT<$50K 60 | 20,000 | CHUDAKOV | 1 | 1 | D | EUGENE C | 11-006 | 11-026 |  |  | 12-021F |  |  |  |  |  |  |  |  |  |  |  |  | APP | 08-016 | 5511 | 09-014 | 11-004 |  |  |  |  |  |  |  |  |
| 15511002 |  | Prepare Procurements/Fabrication Packages 2010 ((TAGGING Mag) | 247d | 2009-10-01 | 2010-09-29 | 9-100M | 211d | 0d |  | MECH ENG [360 h]; MECH DES [360 h] | 39,992.4 | CHUDAKOV | 1 | 1 | D | EUGENE C | 11-006 | 11-026 |  |  |  |  |  |  |  |  |  |  |  |  |  |  |  |  |  |  | 09-014 |  | 2 | 07-024 | 09-027 | 09-027 | 11-030 |  |  |  |
| 15511010E |  | FY10 Travel (TAGGING Mag) | 248d | 2009-10-01 | 2010-09-30 | 9-100M | 84d | 0d |  | TRAVEL | 6,074.08 | CHUDAKOV | 1 | 1 | D | EUGENE C | 11-006 | 11-026 |  |  |  |  |  |  |  |  |  |  |  |  |  |  |  |  |  |  |  |  |  | 07-024 |  |  |  |  |  |  |
| 15511005 |  | Drawings for Yoke Steel (TAGGING Mag) | 120d | 2010-04-01 | 2010-09-20 | 9-100M FS+120d, 12351055M | 274d | 0d |  | MECH ENG [160 h]; MECH DES [440 h]; CONTRB UNIV LBR [240 h]; VISTNG USERS [880 h] | 46,413.6 | CHUDAKOV | 1 | 1 | D | EUGENE C | 11-006 | 11-026 |  |  |  |  |  |  |  |  |  |  |  |  |  |  |  |  |  |  | 09-014 |  |  |  |  |  | 11-030 |  |  |  |
| 15511010 |  | Drawings for Coils (TAGGING Mag) | 100d | 2010-04-01 | 2010-08-20 | 15511005 FS-120d, 9-100M FS+120d | 274d | 0d |  | CONTRB UNIV LBR [240 h]; PD UNIV STUDNT [880 h]; MECH ENG [160 h]; MECH DES [440 h]; VISTNG USERS [880 h] | 55,231.2 | CHUDAKOV | 1 | 1 | D | EUGENE C | 11-006 | 11-026 |  |  |  |  |  |  |  |  |  |  |  |  |  |  |  |  |  |  | 09-014 |  |  |  |  |  | 11-030 |  |  |  |
| 15511015 |  | Drawings for Vac Chamb (TAGGING Mag) | 120d | 2010-04-01 | 2010-09-20 | 9-100M FS+120d, 15511010 FS-100d | 274d | 0d |  | VISTNG USERS [880 h]; PD UNIV STUDNT [880 h]; MECH DES [440 h]; CONTRB UNIV LBR [240 h]; MECH ENG [160 h] | 55,231.2 | CHUDAKOV | 1 | 1 | D | EUGENE C | 11-006 | 11-026 |  |  |  |  |  |  |  |  |  |  |  |  |  |  |  |  |  |  | 09-014 |  |  |  |  |  | 11-030 |  |  |  |
| 15511025 |  | Dsgn Stands for Mag (TAGGING Mag) | 60d | 2010-04-01 | 2010-06-24 | 15511010 FS-100d, 9-100M FS+120d | 334d | 60d |  | MECH ENG [160 h]; VISTNG USERS [880 h]; MECH DES [440 h] | 46,413.6 | CHUDAKOV | 1 | 1 | D | EUGENE C | 11-006 | 11-026 |  |  |  |  |  |  |  |  |  |  |  |  |  |  |  |  |  |  | 09-014 |  |  |  |  |  | 11-030 |  |  |  |
| 15511030 |  | Dsgn Supprt for Vac Chamb (TAGGING Mag) | 110d | 2010-04-01 | 2010-09-03 | 9-100M FS+120d, 15511015 FS-120d | 284d | 10d |  | VISTNG USERS [880 h]; MECH ENG [160 h]; MECH DES [440 h] | 46,413.6 | CHUDAKOV | 1 | 1 | D | EUGENE C | 11-006 | 11-026 |  |  |  |  |  |  |  |  |  |  |  |  |  |  |  |  |  |  | 09-014 |  |  |  |  |  | 11-030 |  |  |  |
| 15511040 |  | Write Pwr Supply Spec (TAGGING Mag) | 25d | 2010-08-23 | 2010-09-27 | 15511010 | 535d | 351d |  | ELEC TECH [200 h]; CONTRB UNIV LBR [240 h] | 8,290 | CHUDAKOV | 1 | 1 | D | EUGENE C | 11-006 | 11-026 |  |  |  |  |  |  |  |  |  |  |  |  |  |  |  |  |  |  | 09-014 |  |  |  |  |  | 11-030 |  |  |  |
| 15511045 |  | EH&S Review of Dsgn before Constrctn (TAGGING Mag) | 5d | 2010-09-21 | 2010-09-27 | 15511010, 15511025, 15511015, 15511030 | 274d | 133d |  |  |  | CHUDAKOV | 1 | 1 | D | EUGENE C | 11-006 | 11-026 |  |  |  |  |  |  |  |  |  |  |  |  |  |  |  |  |  |  | 09-014 |  |  |  |  |  | 11-030 |  |  |  |
| 15511011E |  | FY11 Travel (TAGGING Mag) | 248d | 2010-10-01 | 2011-09-30 | 15511010E | 84d | 0d |  | TRAVEL | 6,267.84 | CHUDAKOV | 1 | 1 | D | EUGENE C | 11-006 | 11-026 |  |  |  |  |  |  |  |  |  |  |  |  |  |  |  |  |  |  |  |  |  | 07-024 |  |  |  |  |  |  |
| 15511004a |  | Engineering Support for Component Procurements FY11 (TAGGING Mag) | 189d | 2011-01-04 | 2011-09-30 | 9-110M FS+59d | 253d | 0d |  | MECH ENG [320 h]; MECH DES [320 h] | 36,681.6 | CHUDAKOV | 1 | 1 | D | EUGENE C | 11-006 | 11-026 |  |  |  |  |  |  |  |  |  |  |  |  |  |  |  |  |  |  | 09-014 |  | 2 | 07-024 | 09-027 | 09-027 | 11-030 |  |  |  |
| 15511003 |  | Evaluate Procurements 2010 (TAGGING Mag) | 164d | 2011-01-05 | 2011-08-26 | 15511002 FS+61d | 211d | 70d |  | MECH ENG [160 h]; MECH DES [40 h] | 12,739.2 | CHUDAKOV | 1 | 1 | D | EUGENE C | 11-006 | 11-026 |  |  |  |  |  |  |  |  |  |  |  |  |  |  |  |  |  |  | 09-014 |  | 2 | 07-024 | 09-027 | 09-027 | 11-030 |  |  |  |
| 15511050 |  | Vend Fab Tagger Magnet Peg Point #1 Submit Foundry reports | 139d | 2011-04-15 | 2011-10-31 | 15511003 FS-164d, 15511045, 9-110M FS+130d | 141d | 0d |  | PROCUREMENT<$50K 60 NO ESCALATION; PROCUREMENT>$50K 69 NO ESCALATION | 442,539.61 | CHUDAKOV | 1 | 1 | D | EUGENE C | 11-006 | 11-026 |  |  |  |  |  |  |  |  |  |  |  |  |  |  |  | APP | 08-016 | 5511 | 09-014 |  |  |  | 09-027 | 09-027 | 11-030 | 10-024 |  |  |
| 15511050a |  | Vend Fab Tagger Magnet Peg Point #2 Winding tooling complete, conductor received | 139d | 2011-04-15 | 2011-10-31 | 15511050 FS-139d | 141d | 0d |  | PROCUREMENT>$50K 69 NO ESCALATION | 45,296 | CHUDAKOV | 1 | 1 | D | EUGENE C | 11-006 | 11-026 |  |  |  |  |  |  |  |  |  |  |  |  |  |  |  | APP |  | 5511 |  |  |  |  |  |  | 11-030 | 10-024 |  |  |
| 15511050b |  | Vend Fab Tagger Magnet Peg Point #3 Submit machining sequence and initial ultrasonice inspection report | 176d | 2011-04-15 | 2011-12-30 | 15511050a FS-139d | 141d | 0d |  | PROCUREMENT>$50K 69 NO ESCALATION | 133,880.2 | CHUDAKOV | 1 | 1 | D | EUGENE C |  |  |  |  |  |  |  |  |  |  |  |  |  |  |  |  |  | APP |  | 5511 |  |  |  |  |  |  | 11-030 |  |  |  |
| 15511050c |  | Vend Fab Tagger Magnet Peg Point #4 Twelve coil assemblies wound | 176d | 2011-04-15 | 2011-12-30 | 15511050b FS-176d | 141d | 0d |  | PROCUREMENT>$50K 69 NO ESCALATION | 78,454.23 | CHUDAKOV | 1 | 1 | D | EUGENE C |  |  |  |  |  |  |  |  |  |  |  |  |  |  |  |  |  | APP |  | 5511 |  |  |  |  |  |  | 11-030 |  |  |  |
| 15511050d |  | Vend Fab Tagger Magnet Peg Point #5 Coil resin impregnation complete | 238d | 2011-04-15 | 2012-03-30 | 15511050c FS-176d | 141d | 0d |  | PROCUREMENT>$50K 69 NO ESCALATION | 102,401.33 | CHUDAKOV | 1 | 1 | D | EUGENE C |  |  |  |  |  |  |  |  |  |  |  |  |  |  |  |  |  | APP |  | 5511 |  |  |  |  |  |  | 11-030 |  |  |  |
| 15511050f |  | Vend Fab Tagger Magnet Peg Point #6 Submit hydrostatic pressure test, flow and pressure test data | 259d | 2011-04-15 | 2012-04-30 | 15511050d FS-238d | 141d | 0d |  | PROCUREMENT>$50K 69 NO ESCALATION | 5,023.33 | CHUDAKOV | 1 | 1 | D | EUGENE C |  |  |  |  |  |  |  |  |  |  |  |  |  |  |  |  |  | APP |  | 5511 |  |  |  |  |  |  | 11-030 |  |  |  |
| 15511050g |  | Vend Fab Tagger Magnet Peg Point #7 Submit dimensional and electrical test data | 281d | 2011-04-15 | 2012-05-31 | 15511050f FS-259d | 141d | 0d |  | PROCUREMENT>$50K 69 NO ESCALATION | 3,892.91 | CHUDAKOV | 1 | 1 | D | EUGENE C |  |  |  |  |  |  |  |  |  |  |  |  |  |  |  |  |  | APP |  | 5511 |  |  |  |  |  |  | 11-030 |  |  |  |
| 15511050h |  | Vend Fab Tagger Magnet Peg Point #8 Submit coil dim. and electrical inspection tests if coil manufactured outside Everso | 301d | 2011-04-15 | 2012-06-29 | 15511050g FS-281d | 141d | 0d |  |  |  | CHUDAKOV | 1 | 1 | D | EUGENE C |  |  |  |  |  |  |  |  |  |  |  |  |  |  |  |  |  | APP |  | 5511 |  |  |  |  |  |  | 11-030 |  |  |  |
| 15511050j |  | Vend Fab Tagger Magnet Peg Point #9 Submit dimension inspection report for core #1 and initial rep. on cores 2,3 and 4 | 346d | 2011-04-15 | 2012-08-31 | 15511050h FS-301d | 141d | 0d |  | PROCUREMENT>$50K 69 NO ESCALATION | 189,643.34 | CHUDAKOV | 1 | 1 | D | EUGENE C |  |  |  |  |  |  |  |  |  |  |  |  |  |  |  |  |  | APP |  | 5511 |  |  |  |  |  |  | 11-030 |  |  |  |
| 15511050k |  | Vend Fab Tagger Magnet Peg Point #10 Magnet assembly complete | 365d | 2011-04-15 | 2012-09-28 | 15511050j FS-346d | 141d | 0d |  | PROCUREMENT>$50K 69 NO ESCALATION | 89,559.87 | CHUDAKOV | 1 | 1 | D | EUGENE C |  |  |  |  |  |  |  |  |  |  |  |  |  |  |  |  |  | APP |  | 5511 |  |  |  |  |  |  | 11-030 |  |  |  |
| 15511050n |  | Vend Fab Tagger Magnet Peg Point #11 Magnet components arrive at JLab | 408d | 2011-04-15 | 2012-11-30 | 15511050k FS-365d | 141d | 0d |  | PROCUREMENT>$50K 69 NO ESCALATION | 13,504 | CHUDAKOV | 1 | 1 | D | EUGENE C |  |  |  |  |  |  |  |  |  |  |  |  |  |  |  |  |  | APP |  | 5511 |  |  |  |  |  |  | 11-030 |  |  |  |
| 15511004 |  | Engineering Support for Magnet Acceptance 2012 (TAGGING Mag) | 50d | 2011-10-03 | 2011-12-13 | 9-120M | 431d | 290d |  | MECH DES [80 h]; MECH ENG [80 h] | 9,463.2 | CHUDAKOV | 1 | 1 | D | EUGENE C | 11-006 | 11-026 |  |  |  |  |  |  |  |  |  |  |  |  |  |  |  |  |  |  | 09-014 |  | 2 | 07-024 | 09-027 | 09-027 | 11-030 |  |  |  |
| 15511004b |  | Engineering Support for Component Procurements FY12 (TAGGING Mag) | 228d | 2011-10-03 | 2012-08-31 | 15511004a | 253d | 112d |  | MECH ENG [240 h]; MECH DES [80 h] | 20,682.4 | CHUDAKOV | 1 | 1 | D | EUGENE C | 11-006 | 11-026 |  |  |  |  |  |  |  |  |  |  |  |  |  |  |  |  |  |  | 09-014 |  | 2 | 07-024 | 09-027 | 09-027 | 11-030 |  |  |  |
| 15511012E |  | FY12 Travel (TAGGING Mag) | 183d | 2011-10-03 | 2012-06-29 | 9-110M, 15511011E | 84d | 64d |  | TRAVEL | 4,848.5 | CHUDAKOV | 1 | 1 | D | EUGENE C | 11-006 | 11-026 |  |  |  |  |  |  |  |  |  |  |  |  |  |  |  |  |  |  |  |  |  | 07-024 |  |  |  |  |  |  |
| 15511035 |  | Dsgn Stands for Quad (TAGGING Mag) | 55d | 2011-10-03 | 2011-12-20 | 9-120M | 580d | 255d |  | VISTNG USERS [880 h]; MECH DES [440 h]; MECH ENG [160 h] | 49,424.4 | CHUDAKOV | 1 | 1 | D | EUGENE C |  | 11-026 |  |  | 12-021F |  |  |  |  |  |  |  |  |  |  |  |  |  |  |  | 09-014 | 11-004 |  |  |  |  |  |  |  |  |
| 15511060 |  | Proc Vac Chamb (TAGGING Mag) | 187d | 2012-01-05 | 2012-09-28 | 15511045, 15511003 FS-164d, 9-120M FS+60d | 184d | 43d |  | PROCUREMENT<$50K 60; PROCUREMENT>$50K 69; VISTNG USERS [120 h] | 80,275.93 | CHUDAKOV | 1 | 1 | D | EUGENE C | 11-006 | 11-026 |  |  |  |  |  |  |  |  |  |  |  |  |  |  |  | APP | 08-016 | 5511 | 09-014 |  |  |  | 09-027 | 09-027 | 11-030 |  |  |  |
| 15511065 |  | Proc Pwr Supply (TAGGING Mag) | 147d | 2012-03-05 | 2012-09-28 | 15511045, 15511040, 9-120M FS+100d | 184d | 43d |  | PROCUREMENT<$50K 60 | 41,276 | CHUDAKOV | 1 | 1 | D | EUGENE C | 11-006 | 11-026 |  |  |  |  |  |  |  |  |  |  |  |  |  |  |  | APP | 08-016 | 5511 | 09-014 |  |  |  |  |  | 11-030 |  |  |  |
| 15511110 |  | Proc. Tagger magnet stands | 107d | 2012-04-03 | 2012-08-31 | 9-120M FS+121d | 267d |  |  | PROCUREMENT<$50K 60 | 17,500 | CHUDAKOV | 1 | 1 | D | EUGENE C |  | 11-026 |  |  | 12-021 |  |  |  |  |  |  |  |  |  |  |  |  | APP |  | 5511 |  |  |  |  |  |  |  |  |  |  |
| 15511095 |  | Proc, calibrate, Install NMR (TAGGING Mag) FY12 | 103d | 2012-05-04 | 2012-09-28 | 9-120M FS+144d, 15511015 | 175d | 0d |  | MECH TECH [29.43 h]; PD UNIV STUDNT [647.43 h]; MECH DES [88.29 h]; MECH ENG [29.43 h] | 14,532.51 | CHUDAKOV | 1 | 1 | D | EUGENE C | 11-006 | 11-026 |  |  | 12-021 |  |  |  |  |  |  |  |  |  |  |  |  | APP |  | 5511 | 09-014 |  |  |  |  |  |  |  | 12-053 |  |
| 15511095b |  | Proc, calibrate, Install NMR (TAGGING Mag) Procurement | 168d | 2012-05-04 | 2013-01-09 | 9-120M FS+144d, 15511015 | 175d | 155d |  | PROCUREMENT<$50K 60 NO ESCALATION FY13 | 37,778.32 | CHUDAKOV | 1 | 1 | D | EUGENE C | 11-006 | 11-026 |  |  | 12-021 |  |  |  |  |  |  |  |  |  |  |  |  | APP |  | 5511 | 09-014 |  |  |  |  |  |  |  | 12-053 |  |
| 15511071 |  | Proc Quad Power Supply (TAGGING Mag) | 102d | 2012-05-07 | 2012-09-28 | 9-120M FS+145d, 15511070 | 424d | 99d |  | PROCUREMENT<$50K 60 | 5,493.93 | CHUDAKOV | 1 | 1 | D | EUGENE C | 11-006 | 11-026 |  |  | 12-021F |  |  |  |  |  |  |  |  |  |  |  |  | APP | 08-016 | 5511 | 09-014 | 11-004 |  |  |  |  |  |  |  |  |
| 15511095a |  | Proc, calibrate, Install NMR (TAGGING Mag) FY13 | 65d | 2012-10-01 | 2013-01-09 | 15511095 | 175d | 155d |  | MECH TECH [18.57 h]; PD UNIV STUDNT [408.57 h]; MECH DES [55.71 h]; MECH ENG [18.57 h] | 9,463.05 | CHUDAKOV | 1 | 1 | D | EUGENE C | 11-006 | 11-026 |  |  | 12-021 |  |  |  |  |  |  |  |  |  |  |  |  | APP |  | 5511 | 09-014 |  |  |  |  |  |  |  | 12-053 |  |
| 15511100 |  | Proc Turbo Pumps (TAGGING Mag) | 20d | 2012-10-01 | 2012-10-26 | 9-130M | 228d |  |  | PROCUREMENT>$50K 69; PROCUREMENT<$50K 60; SKLLD TRADE [200 h] | 69,202.18 | CHUDAKOV | 1 | 1 | D | EUGENE C |  | 11-026 |  |  |  |  |  |  |  |  |  |  |  |  |  |  |  | APP |  | 5511 |  |  |  |  |  |  |  |  |  |  |
| 15511115 |  | Proc. Tagger beamline stands | 75d | 2012-11-02 | 2013-02-28 | 9-130M FS+24d | 325d | 0d |  | PROCUREMENT<$50K 60 | 14,446.6 | CHUDAKOV | 1 | 1 | D | EUGENE C |  | 11-026 |  |  | 12-021 |  |  |  |  |  |  | 12-054F |  |  |  |  |  | APP |  | 5511 |  |  |  |  |  |  |  |  |  |  |
| 15511105 |  | Tagger Magnet Acceptance Test (TAGGING Mag) | 1d | 2012-12-03 | 2012-12-03 | 15511004 FS-50d, 15511004b FS-50d, 15511065, 15511050n, 15511060 | 141d | 0d |  |  |  | CHUDAKOV | 1 | 1 | D | EUGENE C | 11-006 | 11-026 |  |  |  |  |  |  |  |  |  |  |  |  |  |  |  |  |  |  | 09-014 |  |  |  | 09-027 | 09-027 | 11-030 |  |  |  |
| 15511120 |  | Re-Baseline Actuals Adjustment | 1d | 2013-08-30 | 2013-08-30 | 9-130M FS+227d | 20d |  |  | PROCUREMENT>$50K 69 NO ESCALATION | 165,011.94 | CHUDAKOV | 1 | 1 |  | EUGENE C |  |  |  |  |  |  | 13-014 | ADJ |  |  |  |  |  |  |  |  |  |  |  |  |  |  |  |  |  |  |  |  |  |  |
| 25511095 |  | Proc, calibrate, Install NMR (TAGGING Mag) FY13 | 20d | 2013-09-03 | 2013-09-30 | 9-130M FS+228d | 125d | 0d | 8/5 M-F w/JLAB Holidays ReBaseline | MECH ENG [20.65 h]; SCIENTIST [41.29 h]; SUPPLIES & MATERIALS; MECH TECH [41.29 h] | 10,112.26 | CHUDAKOV | 1 | 1 | D | EUGENE C | 11-006 | 11-026 |  |  | 12-021 |  |  |  | 25511095 | S |  |  | EJ | 13-015 | PR |  |  | APP |  | 5511 | 09-014 |  |  |  |  |  |  |  | 12-053 | EJ |
| 25511095a |  | Proc, calibrate, Install NMR (TAGGING Mag) FY14 | 11d | 2013-10-01 | 2013-10-15 | 25511095, 9-130M FS+228d | 125d | 1d | 8/5 M-F w/JLAB Holidays ReBaseline | MECH ENG [11.35 h]; SCIENTIST [22.71 h]; SUPPLIES & MATERIALS; MECH TECH [22.71 h] | 5,738.6 | CHUDAKOV | 1 | 1 | D | EUGENE C | 11-006 | 11-026 |  |  | 12-021 |  |  |  | 25511095 | S |  |  | EJ | 13-015 | PR |  | 14-001 | APP |  | 5511 | 09-014 |  |  |  |  |  |  |  | 12-053 | EJ |

| ID | WBS | Activity | Duration | Start | Finish | Predecessors | Total float | Free float | Calendar | Resources | Cost | RESP - Responsibility | STRT%COMP for CM EVM | FNSH%COMP for CM EVM | 12 GeV 2nd level Critical Path | HALL D Related Milestones | CR 07-024 | CAM RESPONSIBLE | CR 09-014 | CR 09-027 | CR 09-027 Repair | CR 11-006 | CR 11-026 | CR 12-034 | CR 12-021 | CR 08-016 | CR 09-012 | CR 12-054 | Profile change | CR 12-055 | CR 13-014 | ReBaseline Actuals Adjustment | Pre Rebaseline Remaining Budget | Original Activity ID Rebaseline | EVMS Reporting Codes | CR 13-007 | BOE Labor | CR 13-015 | Previously In Progress | Post Rebaseline | Over Under Fixed | BOE Procurement | Obligated Prior to Rebaseline | BOE Expenses | CR 14-001 |
| --- | --- | --- | --- | --- | --- | --- | --- | --- | --- | --- | --- | --- | --- | --- | --- | --- | --- | --- | --- | --- | --- | --- | --- | --- | --- | --- | --- | --- | --- | --- | --- | --- | --- | --- | --- | --- | --- | --- | --- | --- | --- | --- | --- | --- | --- |
|  | 2 | **1.5.5.1.2 HODOSCOPE** |  | 2011-10-03 | 2014-04-01 |  |  |  |  |  |  |  |  |  |  |  |  |  |  |  |  |  |  |  |  |  |  |  |  |  |  |  |  |  |  |  |  |  |  |  |  |  |  |  |  |
| 15512004 |  | Prepare Procurement/Fabrication Packages 2012(HODOSCP) | 247d | 2011-10-03 | 2012-09-28 | 9-120M | 178d | 43d |  | MECH ENG [160 h]; MECH DES [320 h] | 26,633.6 | CHUDAKOV | 1 | 1 | 2 | D | 07-024 | EUGENE C | 09-014 | 09-027 | 09-027 | 11-006 | 11-026 |  |  |  |  |  |  |  |  |  |  |  |  |  |  |  |  |  |  |  |  |  |  |
| 15512012E |  | FY12 Travel (HODOSCP) | 247d | 2011-10-03 | 2012-09-28 | 9-120M | 20d | 0d |  | TRAVEL | 884.52 | CHUDAKOV | 1 | 1 |  | D | 07-024 | EUGENE C |  | 09-027 | 09-027 | 11-006 | 11-026 |  |  |  |  |  |  |  |  |  |  |  |  |  |  |  |  |  |  |  |  |  |  |
| 15512136 |  | Design & Layout Preamp Cards (HODOSCP) | 160d | 2011-10-03 | 2012-05-25 | 12351055M, 9-120M | 335d |  |  | CONTRB UNIV LBR [1280 h] |  | CHUDAKOV | 1 | 1 |  | D |  | EUGENE C |  |  |  | 11-006 | 11-026 | 12-034F |  |  |  |  |  |  |  |  |  |  |  |  |  |  |  |  |  |  |  |  |  |
| 15512001 |  | Prepare Procurements for Thin Window Test 2011 (HODOSCP) | 46d | 2012-01-05 | 2012-03-12 | 9-120M FS+60d | 169d | 34d |  | MECH ENG [160 h]; MECH DES [80 h] | 15,072.8 | CHUDAKOV | 1 | 1 | 2 | D | 07-024 | EUGENE C | 09-014 | 09-027 | 09-027 | 11-006 | 11-026 |  |  |  |  |  |  |  |  |  |  |  |  |  |  |  |  |  |  |  |  |  |  |
| 15512020 |  | AL Foil for Thin Window (HODOSCP) | 20d | 2012-01-05 | 2012-02-02 | 9-120M FS+60d | 135d | 0d |  | PROCUREMENT<$50K 60 | 1,614.61 | CHUDAKOV | 1 | 1 |  | D | 07-024 | EUGENE C |  |  |  | 11-006 | 11-026 |  |  |  |  |  |  |  |  |  |  |  |  |  |  |  |  |  |  |  |  |  |  |
| 15512170 |  | Purchase Power Supply for DAC Chips (HODOSCP) | 10d | 2012-01-05 | 2012-01-19 | 9-120M FS+60d | 425d |  |  | PROCUREMENT<$50K 60 | 2,380.95 | CHUDAKOV | 1 | 1 |  | D |  | EUGENE C |  |  |  | 11-006 | 11-026 | 12-034F |  |  |  |  |  |  |  |  |  |  |  |  |  |  |  |  |  |  |  |  |  |
| 15512120 |  | Proc Cables for Microscope (HODOSCP) | 127d | 2012-03-06 | 2012-08-31 | 9-120M FS+101d, 12351055M | 267d |  |  | PROCUREMENT>$50K 69 | 912.6 | CHUDAKOV | 1 | 1 |  | D |  | EUGENE C |  |  |  | 11-006 | 11-026 | 12-034F | 12-021 |  |  |  |  |  |  |  |  |  |  |  |  |  |  |  |  |  |  |  |  |
| 15512100 |  | Proc Fibers for Microscope (HODOSCP) | 104d | 2012-04-02 | 2012-08-27 | 9-120M FS+120d, 12351055M | 271d |  |  | PROCUREMENT>$50K 69 | 12,285.06 | CHUDAKOV | 1 | 1 |  | D |  | EUGENE C |  |  |  | 11-006 | 11-026 | 12-034F | 12-021 |  |  |  |  |  |  |  |  |  |  |  |  |  |  |  |  |  |  |  |  |
| 15512025 |  | Frame & Vacuum System for Limit Test of Thin Window (HODOSCP) | 130d | 2012-04-30 | 2012-10-31 | 15512001, 15512020 FS+60d | 135d | 0d |  | PROCUREMENT<$50K 60 NO ESCALATION FY13 | 23,400.11 | CHUDAKOV | 1 | 1 |  | D | 07-024 | EUGENE C |  | 09-027 | 09-027 | 11-006 | 11-026 |  |  | 08-016 | 09-012 |  |  |  |  |  |  |  |  |  |  |  |  |  |  |  |  |  |  |
| 15512005 |  | Design Hodoscope Supprt (HODOSCP) | 59d | 2012-07-09 | 2012-09-28 | 9-120M FS+188d | 71d | 0d |  | PD UNIV STUDNT [640 h]; MECH DES [440 h]; MECH TECH [320 h] | 42,244.4 | CHUDAKOV | 1 | 1 |  | D |  | EUGENE C |  |  |  | 11-006 | 11-026 | 12-034F | 12-021 |  |  | 12-054F |  |  |  |  |  |  |  |  |  |  |  |  |  |  |  |  |  |
| 15512110 |  | Proc SiPMs for Microscope (HODOSCP) Part A | 156d | 2012-07-11 | 2013-02-28 | 9-120M FS+190d | 149d |  |  | PROCUREMENT<$50K 60 NO ESCALATION FY13 | 42,400.71 | CHUDAKOV | 1 | 1 |  | D |  | EUGENE C |  |  |  | 11-006 | 11-026 | 12-034 | 12-021 |  |  |  | C | 12-055 |  |  |  |  |  |  |  |  |  |  |  |  |  |  |  |
| 15512110a |  | Proc SiPMs for Microscope (HODOSCP) Part B | 156d | 2012-07-11 | 2013-02-28 | 9-120M FS+190d | 149d |  |  | PROCUREMENT<$50K 60 NO ESCALATION FY13; PROCUREMENT>$50K 69 NO ESCALATION FY13 | 98,000 | CHUDAKOV | 1 | 1 |  | D |  | EUGENE C |  |  |  | 11-006 | 11-026 | 12-034 | 12-021 |  |  |  | C | 12-055 |  |  |  |  |  |  |  |  |  |  |  |  |  |  |  |
| 15512013E |  | FY13 Travel (HODOSCP) | 228d | 2012-10-01 | 2013-08-30 | 15512012E, 15511012E | 20d |  |  | TRAVEL | 839.13 | CHUDAKOV | 1 | 1 |  | D | 07-024 | EUGENE C |  |  |  | 11-006 | 11-026 |  |  |  |  |  |  |  | 13-014 |  |  |  |  |  |  |  |  |  |  |  |  |  |  |
| 15512050 |  | Proc PMTs for Fixed Array (HODOSCP) | 142d | 2012-10-01 | 2013-04-30 | 9-130M | 106d |  |  | PROCUREMENT>$50K 69 | 54,933.48 | CHUDAKOV | 1 | 1 |  | D | 07-024 | EUGENE C |  |  |  | 11-006 | 11-026 | 12-034 | 12-021 |  |  |  |  |  |  |  |  |  |  |  |  |  |  |  |  |  |  |  |  |
| 15512055 |  | Proc Dividers for Fixed Array (HODOSCP) | 142d | 2012-10-01 | 2013-04-30 | 9-130M | 106d |  |  | PROCUREMENT>$50K 69 | 32,622.03 | CHUDAKOV | 1 | 1 |  | D | 07-024 | EUGENE C |  |  |  | 11-006 | 11-026 | 12-034 | 12-021 |  |  |  |  |  |  |  |  |  |  |  |  |  |  |  |  |  |  |  |  |
| 15512002 |  | Engineering Support for Testing Thin Window (HODOSCP) | 45d | 2012-11-01 | 2013-01-14 | 9-130M FS+23d | 135d | 0d |  | MECH ENG [160 h]; MECH DES [320 h] | 27,484.8 | CHUDAKOV | 1 | 1 | 2 | D | 07-024 | EUGENE C | 09-014 | 09-027 | 09-027 | 11-006 | 11-026 |  |  |  |  |  |  |  |  |  |  |  |  |  |  |  |  |  |  |  |  |  |  |
| 15512030 |  | Test Window to limit (HODOSCP) | 45d | 2012-11-01 | 2013-01-14 | 15512025, 15512002 FS-45d | 135d | 0d |  | MECH TECH [440 h]; CONTRB UNIV LBR [1200 h] | 20,178.4 | CHUDAKOV | 1 | 1 |  | D |  | EUGENE C |  | 09-027 | 09-027 | 11-006 | 11-026 |  |  |  |  |  |  |  |  |  |  |  |  |  |  |  |  |  |  |  |  |  |  |
| 15512003 |  | Prepare Procurement/Fabrication Packages 2013 (HODOSCP) | 25d | 2012-12-03 | 2013-01-14 | 9-130M FS+43d, 15512004 | 135d | 0d |  | MECH ENG [120 h]; MECH DES [320 h] | 24,590.4 | CHUDAKOV | 1 | 1 | 2 | D | 07-024 | EUGENE C | 09-014 | 09-027 | 09-027 | 11-006 | 11-026 |  |  |  |  |  |  |  |  |  |  |  |  |  |  |  |  |  |  |  |  |  |  |
| 15512035 |  | Fab Final Thin Exit Window & AL Flange (HODOSCP) | 45d | 2013-01-15 | 2013-03-20 | 15512030, 15512003 | 135d |  |  | PROCUREMENT<$50K 60 | 24,146.57 | CHUDAKOV | 1 | 1 |  | D | 07-024 | EUGENE C |  | 09-027 | 09-027 | 11-006 | 11-026 |  |  |  |  |  |  |  |  |  |  |  |  |  |  |  |  |  |  |  |  |  |  |
| 15512005a |  | Construct Hodoscope Supprt (HODOSCP) | 52d | 2013-04-08 | 2013-06-19 | 15512005 FS+125d | 71d |  |  | PROCUREMENT<$50K 60 | 23,424.13 | CHUDAKOV | 1 | 1 |  | D |  | EUGENE C |  |  |  | 11-006 | 11-026 | 12-034F | 12-021 |  |  | 12-054 |  |  |  |  |  |  |  |  |  |  |  |  |  |  |  |  |  |
| 15512175 |  | Re-Baseline Actuals Adjustment | 1d | 2013-08-30 | 2013-08-30 | 9-130M FS+227d | 20d |  |  | PROCUREMENT>$50K 69 NO ESCALATION | -119,497.81 | CHUDAKOV | 1 | 1 |  |  |  | EUGENE C |  |  |  |  |  |  |  |  |  |  |  |  | 13-014 | ADJ |  |  |  |  |  |  |  |  |  |  |  |  |  |
| 25512005 |  | Design Hodoscope Supprt (HODOSCP) FY13 | 20d | 2013-09-03 | 2013-09-30 | 9-130M FS+228d | 147d | 0d | 8/5 M-F w/JLAB Holidays ReBaseline | MECH ENG [29.03 h]; MECH DES [22.58 h] | 3,223.08 | CHUDAKOV | 1 | 1 |  | D |  | EUGENE C |  |  |  | 11-006 | 11-026 | 12-034F | 12-021 |  |  | 12-054F |  |  |  |  | 42244.4 | 25512005 | S | 13-007F | PE | 13-015 | Review | PR |  |  |  |  |  |
| 25512010 |  | Catholic University Tagger Hodoscope Fixed Array | 140d | 2013-09-03 | 2014-04-01 | 9-130M FS+228d | 67d | 0d | 8/5 M-F w/JLAB Holidays ReBaseline | PROCUREMENT<$50K 60 NO ESCALATION FY14 | 45,007 | CHUDAKOV | 1 | 1 |  | D |  | EUGENE C |  |  |  | 11-006 | 11-026 | 12-034 | 12-021 |  |  | 12-054 |  |  |  |  |  | 25512010 | D | 13-007 |  | 13-015 |  | PR | y | OB | OB |  |  |
| 25512010a |  | Catholic University Tagger Hodoscope Fixed Array Oversight FY13 | 20d | 2013-09-03 | 2013-09-30 | 9-130M FS+228d | 89d | 0d | 8/5 M-F w/JLAB Holidays ReBaseline | MECH ENG [1.62 h] | 117.22 | CHUDAKOV | 1 | 1 |  | D |  | EUGENE C |  |  |  | 11-006 | 11-026 | 12-034 | 12-021 |  |  | 12-054 |  |  |  |  |  | 25512010a | E | 13-007 | EJ | 13-015 |  | PR |  |  |  |  |  |
| 25512013LOE |  | FY13 Travel (HODOSCP) | 20d | 2013-09-03 | 2013-09-30 | 9-130M FS+228d | 187d | 120d | 8/5 M-F w/JLAB Holidays ReBaseline | TRAVEL | 245.32 | CHUDAKOV | 1 | 1 |  | D | 07-024 | EUGENE C |  |  |  | 11-006 | 11-026 |  |  |  |  |  |  |  |  |  |  | 25512013LOE | E |  |  | 13-015 |  | PR |  |  |  | PE |  |
| 25512056 |  | Manufacturing Drawings for Hodoscope mag shield (HODOSCP) | 20d | 2013-09-03 | 2013-09-30 | 9-130M FS+228d | 150d | 0d | 8/5 M-F w/JLAB Holidays ReBaseline | MECH DES [19.2 h]; MECH ENG [9.6 h] | 1,649.09 | CHUDAKOV | 1 | 1 |  | D | 07-024 | EUGENE C |  |  |  | 11-006 | 11-026 | 12-034 | 12-021 |  |  |  |  |  |  |  |  | 25512056 | S | 13-007 | PE | 13-015 |  | PR |  |  |  |  |  |
| 25512065 |  | Manufacturing Drawings for microscope cooling FY13 | 20d | 2013-09-03 | 2013-09-30 | 9-130M FS+228d | 69d | 0d | 8/5 M-F w/JLAB Holidays ReBaseline | MECH ENG [15.01 h]; MECH DES [17.74 h] | 1,967.98 | CHUDAKOV | 1 | 1 |  | D |  | EUGENE C |  |  |  |  |  |  |  |  |  |  |  |  |  |  |  | 25512065 | S | 13-007 | PE | 13-015 |  | PR |  |  |  |  |  |
| 25512131 |  | UConn TAGM Contract - Procurement of Supplies for Construction | 20d | 2013-09-03 | 2013-09-30 | 9-130M FS+228d | 89d | 0d | 8/5 M-F w/JLAB Holidays ReBaseline | PROCUREMENT<$50K 60 NO ESCALATION | 3,500 | CHUDAKOV | 1 | 1 |  | D |  | EUGENE C |  |  |  | 11-006 | 11-026 | 12-034 | 12-021 |  |  |  |  |  |  |  |  | 25512131 | D |  |  | 13-015 |  | PR | y | OB | OB |  |  |
| 25512136 |  | UConn TAGM Contract - Production 1st Article Opt Fib Bundle | 20d | 2013-09-03 | 2013-09-30 | 25512131 FS-20d | 89d | 0d | 8/5 M-F w/JLAB Holidays ReBaseline | PROCUREMENT<$50K 60 NO ESCALATION | 3,329.1 | CHUDAKOV | 1 | 1 |  | D |  | EUGENE C |  |  |  | 11-006 | 11-026 | 12-034 | 12-021 |  |  |  |  |  |  |  |  | 25512136 | D |  |  | 13-015 |  | PR | y | OB | OB |  |  |
| 25512146 |  | UConn TAGM Contract - Complete Construction of TAGM Enclosure | 62d | 2013-09-03 | 2013-11-27 | 25512136 FS-20d | 89d | 0d | 8/5 M-F w/JLAB Holidays ReBaseline | PROCUREMENT<$50K 60 NO ESCALATION | 3,446.8 | CHUDAKOV | 1 | 1 |  | D |  | EUGENE C |  |  |  | 11-006 | 11-026 | 12-034 | 12-021 |  |  |  |  |  |  |  |  | 25512146 | D |  |  | 13-015 |  | PR | y | OB | OB |  |  |
| 25512151 |  | UConn TAGM Contract - Testing of TAGM Electronic Boards | 20d | 2013-09-03 | 2013-09-30 | 25512146 FS-62d | 89d | 0d | 8/5 M-F w/JLAB Holidays ReBaseline | PROCUREMENT<$50K 60 NO ESCALATION | 2,017.2 | CHUDAKOV | 1 | 1 |  | D |  | EUGENE C |  |  |  | 11-006 | 11-026 | 12-034 | 12-021 |  |  |  |  |  |  |  |  | 25512151 | D |  |  | 13-015 |  | PR | y | OB | OB |  |  |
| 25512156 |  | UConn TAGM Contract - Complete 20 Optical Fiber Bundles | 77d | 2013-09-03 | 2013-12-20 | 25512151 FS-20d | 89d | 0d | 8/5 M-F w/JLAB Holidays ReBaseline | PROCUREMENT<$50K 60 NO ESCALATION; PROCUREMENT>$50K 69 NO ESCALATION | 28,938.47 | CHUDAKOV | 1 | 1 |  | D |  | EUGENE C |  |  |  | 11-006 | 11-026 | 12-034 | 12-021 |  |  |  |  |  |  |  |  | 25512156 | D |  |  | 13-015 |  | PR | y | OB | OB |  |  |
| 25512161 |  | UConn TAGM Contract - Complete Construction of Fiber Array Enclosure | 77d | 2013-09-03 | 2013-12-20 | 25512156 FS-77d | 89d | 0d | 8/5 M-F w/JLAB Holidays ReBaseline | PROCUREMENT>$50K 69 NO ESCALATION | 3,571.6 | CHUDAKOV | 1 | 1 |  | D |  | EUGENE C |  |  |  | 11-006 | 11-026 | 12-034 | 12-021 |  |  |  |  |  |  |  |  | 25512161 | D |  |  | 13-015 |  | PR | y | OB | OB |  |  |
| 25512166 |  | UConn TAGM Contract - Complete Assembly of Full Enclosure at UConn | 98d | 2013-09-03 | 2014-01-31 | 25512161 FS-77d | 89d | 0d | 8/5 M-F w/JLAB Holidays ReBaseline | PROCUREMENT>$50K 69 NO ESCALATION | 3,782.2 | CHUDAKOV | 1 | 1 |  | D |  | EUGENE C |  |  |  | 11-006 | 11-026 | 12-034 | 12-021 |  |  |  |  |  |  |  |  | 25512166 | D |  |  | 13-015 |  | PR | y | OB | OB |  |  |
| 25512171 |  | UConn TAGM Contract - Disassemble TAGM and Prepare for Shipment to JLab | 118d | 2013-09-03 | 2014-02-28 | 25512166 FS-98d | 89d | 0d | 8/5 M-F w/JLAB Holidays ReBaseline | PROCUREMENT>$50K 69 NO ESCALATION | 2,627.4 | CHUDAKOV | 1 | 1 |  | D |  | EUGENE C |  |  |  | 11-006 | 11-026 | 12-034 | 12-021 |  |  |  |  |  |  |  |  | 25512171 | D |  |  | 13-015 |  | PR | y | OB | OB |  |  |
| 25512176 |  | UConn TAGM Contract - TAGM Delivered to JLab | 118d | 2013-09-03 | 2014-02-28 | 25512171 FS-118d | 89d | 22d | 8/5 M-F w/JLAB Holidays ReBaseline | PROCUREMENT>$50K 69 NO ESCALATION | 2,627.4 | CHUDAKOV | 1 | 1 |  | D |  | EUGENE C |  |  |  | 11-006 | 11-026 | 12-034 | 12-021 |  |  |  |  |  |  |  |  | 25512176 | D |  |  | 13-015 |  | PR | y | OB | OB |  |  |
| 25512005b |  | Design Hodoscope Supprt (HODOSCP) FY14 | 11d | 2013-10-01 | 2013-10-15 | 9-130M FS+228d, 25512005 | 147d | 0d | 8/5 M-F w/JLAB Holidays ReBaseline | MECH DES [12.42 h]; MECH ENG [15.97 h] | 1,829.61 | CHUDAKOV | 1 | 1 |  | D |  | EUGENE C |  |  |  | 11-006 | 11-026 | 12-034F | 12-021 |  |  | 12-054F |  |  |  |  | 42244.4 | 25512005 | S | 13-007F | PE | 13-015 | Review | PR |  |  |  |  | 14-001 |
| 25512010aa |  | Catholic University Tagger Hodoscope Fixed Array Oversight FY14 | 98d | 2013-10-01 | 2014-02-28 | 25512010a, 9-130M FS+228d | 89d | 22d | 8/5 M-F w/JLAB Holidays ReBaseline | MECH ENG [7.93 h] | 592.13 | CHUDAKOV | 1 | 1 |  | D |  | EUGENE C |  |  |  | 11-006 | 11-026 | 12-034 | 12-021 |  |  | 12-054 |  |  |  |  |  | 25512010a | E | 13-007 | EJ | 13-015 |  | PR |  |  |  |  | 14-001 |
| 25512060 |  | Fab Hodoscope mag shields | 37d | 2013-10-01 | 2013-11-20 | 25512056 | 150d | 83d | 8/5 M-F w/JLAB Holidays ReBaseline | PROCUREMENT<$50K 60 | 8,255.2 | CHUDAKOV | 1 | 1 |  | D |  | EUGENE C |  |  |  |  |  |  |  |  |  |  |  |  |  |  |  | 25512060 | D | 13-007 |  | 13-015 |  | PR |  | PE |  |  | 14-001 |
| 25512065a |  | Manufacturing Drawings for microscope cooling FY14 | 82d | 2013-10-01 | 2014-02-06 | 25512065, 9-130M FS+228d | 69d | 0d | 8/5 M-F w/JLAB Holidays ReBaseline | MECH ENG [61.55 h]; MECH DES [72.74 h] | 8,327.49 | CHUDAKOV | 1 | 1 |  | D |  | EUGENE C |  |  |  |  |  |  |  |  |  |  |  |  |  |  |  | 25512065 | S | 13-007 | PE | 13-015 |  | PR |  |  |  |  | 14-001 |
| 25512005a |  | Construct Hodoscope Supprt (HODOSCP) Part A | 30d | 2013-10-15 | 2013-11-25 | 25512005 FS-1d, 25512005b FS-1d | 147d | 80d | 8/5 M-F w/JLAB Holidays ReBaseline | PROCUREMENT<$50K 60 | 24,171.36 | CHUDAKOV | 1 | 1 |  | D |  | EUGENE C |  |  |  | 11-006 | 11-026 | 12-034F | 12-021 |  |  | 12-054 |  |  |  |  |  | 25512005a | D | 13-007 |  | 13-015 |  | PR |  | EJ |  |  | 14-001 |
| 25512070 |  | Fab microscope cooling | 23d | 2014-02-26 | 2014-03-28 | 25512065a FS+13d, 25512065 FS+13d | 69d | 2d | 8/5 M-F w/JLAB Holidays ReBaseline | PROCUREMENT<$50K 60; SUPPLIES & MATERIALS | 7,326.49 | CHUDAKOV | 1 | 1 |  | D |  | EUGENE C |  |  |  |  |  |  |  |  |  |  |  |  |  |  |  | 25512070 | D | 13-007 |  | 13-015 |  | PR |  | EJ |  | EJ | 14-001 |

| ID | WBS | Activity | Duration | Start | Finish | Predecessors | Total float | Free float | Calendar | Resources | Cost | RESP - Responsibility | STRT%COMP for CM EVM | FNSH%COMP for CM EVM | 12 GeV 2nd level Critical Path | HALL D Related Milestones | CR 07-024 | CAM RESPONSIBLE | CR 09-014 | CR 09-027 | CR 09-027 Repair | CR 11-006 | CR 11-026 | CR 12-021 | CR 12-054 | CR 12-001 | CR 10-042 | CR 12-053 | CR 08-016 | CR 13-014 | ReBaseline Actuals Adjustment | Original Activity ID Rebaseline | EVMS Reporting Codes | CR 13-007 | BOE Labor | CR 13-015 | Previously In Progress | Post Rebaseline | BOE Procurement | BOE Expenses | Over Under Fixed | Obligated Prior to Rebaseline | CR 14-001 |
| --- | --- | --- | --- | --- | --- | --- | --- | --- | --- | --- | --- | --- | --- | --- | --- | --- | --- | --- | --- | --- | --- | --- | --- | --- | --- | --- | --- | --- | --- | --- | --- | --- | --- | --- | --- | --- | --- | --- | --- | --- | --- | --- | --- |
|  | 2 | **1.5.5.2 TARGET** |  | 2011-04-01 | 2014-08-18 |  |  |  |  |  |  |  |  |  |  |  |  |  |  |  |  |  |  |  |  |  |  |  |  |  |  |  |  |  |  |  |  |  |  |  |  |  |  |
| 1552001 |  | Prepare Procurements/Fabrication Packages 2012 (TARGET) | 128d | 2011-04-01 | 2011-09-30 | 9-110M FS+120d | 377d | 0d |  | MECH DES [160 h]; MECH ENG [160 h] | 18,340.8 | CHUDAKOV | 1 | 1 | 2 | D | 07-024 | EUGENE C | 09-014 | 09-027 | 09-027 | 11-006 | 11-026 | 12-021F | 12-054F |  |  |  |  |  |  |  |  |  |  |  |  |  |  |  |  |  |  |
| 1552004 |  | Develop gas handling system | 108d | 2011-04-01 | 2011-09-01 | 9-110M FS+120d | 486d | 357d |  | MECH TECH [240 h]; MECH DES [240 h]; MECH ENG [320 h] | 43,284 | CHUDAKOV | 1 | 1 |  | D | 07-024 | EUGENE C |  | 09-027 | 09-027 | 11-006 | 11-026 | 12-021F | 12-054F |  |  |  |  |  |  |  |  |  |  |  |  |  |  |  |  |  |  |
| 1552002 |  | Evaluate Procuements 2012 (TARGET) FY11 | 101d | 2011-05-10 | 2011-09-30 | 1552001 FS-101d | 377d | 0d |  | MECH DES [16.16 h]; MECH ENG [32.32 h] | 2,950.49 | CHUDAKOV | 1 | 1 | 2 | D | 07-024 | EUGENE C | 09-014 | 09-027 | 09-027 | 11-006 | 11-026 | 12-021F | 12-054F | 12-001 |  |  |  |  |  |  |  |  |  |  |  |  |  |  |  |  |  |
| 1552032 |  | Develop cryo system design | 86d | 2011-06-01 | 2011-09-30 | 9-110M FS+162d | 327d | 307d |  | MECH DES [240 h]; MECH ENG [320 h]; MECH TECH [240 h] | 43,284 | CHUDAKOV | 1 | 1 |  | D | 07-024 | EUGENE C |  | 09-027 | 09-027 | 11-006 | 11-026 | 12-021F | 12-054F |  | 10-042 |  |  |  |  |  |  |  |  |  |  |  |  |  |  |  |  |
| 1552002a |  | Evaluate Procuements 2012 (TARGET) FY12 | 149d | 2011-10-03 | 2012-05-10 | 1552002 | 377d | 151d |  | MECH DES [23.84 h]; MECH ENG [47.68 h] | 4,491.69 | CHUDAKOV | 1 | 1 | 2 | D | 07-024 | EUGENE C | 09-014 | 09-027 | 09-027 | 11-006 | 11-026 | 12-021F | 12-054F | 12-001 |  |  |  |  |  |  |  |  |  |  |  |  |  |  |  |  |  |
| 1552030 |  | Proc Liquid Helium refrigerator (TARGET) | 80d | 2011-10-03 | 2012-02-02 | 1552003 FS-300d, 1552002a FS-300d, 9-120M | 394d | 374d |  | PROCUREMENT>$50K 69; PROCUREMENT<$50K 60 | 56,754.5 | CHUDAKOV | 1 | 1 |  | D | 07-024 | EUGENE C |  | 09-027 | 09-027 | 11-006 | 11-026 | 12-021F | 12-054F |  | 10-042 |  |  |  |  |  |  |  |  |  |  |  |  |  |  |  |  |
| 1552003 |  | FY12 Engineering Support for Assembly (TARGET) | 130d | 2012-01-05 | 2012-07-10 | 9-120M FS+60d | 267d | 110d |  | MECH ENG [240 h]; MECH DES [480 h] | 39,950.4 | CHUDAKOV | 1 | 1 | 2 | D | 07-024 | EUGENE C | 09-014 | 09-027 | 09-027 | 11-006 | 11-026 | 12-021F | 12-054F |  |  |  |  |  |  |  |  |  |  |  |  |  |  |  |  |  |  |
| 1552018 |  | Fab Outer Vac/Scattering Chamb (TARGET) Labor Original | 18d | 2012-01-05 | 2012-01-31 | 9-120M FS+60d | 207d | 0d |  | MECH ENG [5.54 h]; MECH TECH [33.23 h] | 1,865.2 | CHUDAKOV | 1 | 1 |  | D | 07-024 | EUGENE C |  | 09-027 | 09-027 | 11-006 | 11-026 | 12-021 | 12-054F |  |  |  |  |  |  |  |  |  |  |  |  |  |  |  |  |  |  |
| 1552023 |  | Fab Target Cells (TARGET) Labor Original | 18d | 2012-01-05 | 2012-01-31 | 9-120M FS+60d | 207d | 0d |  | MECH TECH [33.23 h] | 1,476.74 | CHUDAKOV | 1 | 1 |  | D | 07-024 | EUGENE C |  | 09-027 | 09-027 | 11-006 | 11-026 | 12-021 | 12-054F |  |  |  |  |  |  |  |  |  |  |  |  |  |  |  |  |  |  |
| 1552023a |  | Fab Target Cells (TARGET) Labor Revised 2012 ETC FY12 | 127d | 2012-04-02 | 2012-09-28 | 1552023 FS+42d | 207d | 0d |  | MECH TECH [178.64 h] | 7,938.76 | CHUDAKOV | 1 | 1 |  | D | 07-024 | EUGENE C |  | 09-027 | 09-027 | 11-006 | 11-026 | 12-021 | 12-054F |  |  | 12-053 |  |  |  |  |  |  |  |  |  |  |  |  |  |  |  |
| 1552018a |  | Fab Outer Vac/Scattering Chamb (TARGET) Labor Revised 2012 ETC | 102d | 2012-05-07 | 2012-09-28 | 1552018 FS+67d | 207d | 170d |  | MECH ENG [34.46 h]; MECH TECH [206.77 h] | 11,605.2 | CHUDAKOV | 1 | 1 |  | D | 07-024 | EUGENE C |  | 09-027 | 09-027 | 11-006 | 11-026 | 12-021 | 12-054F |  |  |  |  |  |  |  |  |  |  |  |  |  |  |  |  |  |  |
| 1552027 |  | Burst test target cell | 64d | 2012-06-06 | 2012-09-04 | 1552025 FS-229d | 245d | 225d |  | MECH TECH [160 h]; MECH ENG [80 h] | 12,720 | CHUDAKOV | 1 | 1 |  | D | 07-024 | EUGENE C |  | 09-027 | 09-027 | 11-006 | 11-026 | 12-021 | 12-054F |  |  |  |  |  |  |  |  |  |  |  |  |  |  |  |  |  |  |
| 1552023aa |  | Fab Target Cells (TARGET) Labor Revised 2012 ETC FY13 | 20d | 2012-10-01 | 2012-10-26 | 1552023 FS+42d, 1552023a | 207d | 127d |  | MECH TECH [28.13 h] | 1,290.04 | CHUDAKOV | 1 | 1 |  | D | 07-024 | EUGENE C |  | 09-027 | 09-027 | 11-006 | 11-026 | 12-021 | 12-054F |  |  | 12-053 |  |  |  |  |  |  |  |  |  |  |  |  |  |  |  |
| 1552025 |  | Fab Target Cells (TARGET) | 147d | 2012-10-01 | 2013-05-07 | 9-130M, 1552023aa FS-147d, 1552003 FS-130d, 1552023a FS-147d, 1552023 FS-130d | 80d | 0d |  | PROCUREMENT<$50K 60 | 12,073.29 | CHUDAKOV | 1 | 1 |  | D | 07-024 | EUGENE C |  | 09-027 | 09-027 | 11-006 | 11-026 | 12-021 | 12-054 |  |  |  |  |  |  |  |  |  |  |  |  |  |  |  |  |  |  |
| 1552035 |  | Fab Positioning/Mounting Sys (TARGET) | 124d | 2012-11-05 | 2013-05-09 | 9-130M FS+25d | 78d | 58d |  | PROCUREMENT<$50K 60 | 59,159.13 | CHUDAKOV | 1 | 1 |  | D | 07-024 | EUGENE C |  | 09-027 | 09-027 | 11-006 | 11-026 | 12-021 | 12-054 |  |  |  |  |  |  |  |  |  |  |  |  |  |  |  |  |  |  |
| 1552020 |  | Fab Outer Vac/Scattering Chamb (TARGET) | 147d | 2012-12-03 | 2013-07-09 | 9-130M FS+43d, 1552003 FS-130d, 1552018 FS-130d, 1552018a FS-127d | 37d | 17d |  | PROCUREMENT<$50K 60 | 10,865.96 | CHUDAKOV | 1 | 1 |  | D | 07-024 | EUGENE C |  | 09-027 | 09-027 | 11-006 | 11-026 | 12-021 | 12-054 |  |  |  |  |  |  |  |  |  |  |  |  |  |  |  |  |  |  |
| 1552033 |  | Procure heat xchngr and cryo hardware | 147d | 2013-01-03 | 2013-08-01 | 1552032, 9-130M FS+60d | 20d | 0d |  | PROCUREMENT<$50K 60 | 15,972.26 | CHUDAKOV | 1 | 1 |  | D | 07-024 | EUGENE C |  | 09-027 | 09-027 | 11-006 | 11-026 | 12-021 | 12-054 |  | 10-042 |  |  |  |  |  |  |  |  |  |  |  |  |  |  |  |  |
| 1552005 |  | Proc Gas Handling Sys (TARGET) | 120d | 2013-02-15 | 2013-08-06 | 1552004, 9-130M FS+90d, 1552002a FS-60d | 129d | 0d |  | PROCUREMENT>$50K 69 | 28,975.9 | CHUDAKOV | 1 | 1 |  | D | 07-024 | EUGENE C |  | 09-027 | 09-027 | 11-006 | 11-026 | 12-021 | 12-054 |  |  |  |  |  |  |  |  |  |  |  |  |  |  |  |  |  |  |
| 1552045 |  | Program controls | 54d | 2013-03-08 | 2013-05-22 | 9-130M FS+104d | 239d | 219d |  |  |  | CHUDAKOV | 1 | 1 |  | D | 07-024 | EUGENE C |  |  |  | 11-006 | 11-026 | 12-021 | 12-054F |  |  |  | 08-016 |  |  |  |  |  |  |  |  |  |  |  |  |  |  |
| 1552010 |  | Proc Controls (TARGET) | 118d | 2013-03-18 | 2013-08-30 | 9-130M FS+110d | 20d |  |  | PROCUREMENT>$50K 69 | 41,854.09 | CHUDAKOV | 1 | 1 |  | D | 07-024 | EUGENE C |  |  |  | 11-006 | 11-026 | 12-021 | 12-054 |  | 10-042 |  |  | 13-014 |  |  |  |  |  |  |  |  |  |  |  |  |  |
| 1552015 |  | Fab Isolation Vac Pumping Sys (TARGET) | 83d | 2013-03-18 | 2013-07-12 | 9-130M FS+110d, 1552003 FS-130d | 94d | 74d |  | PROCUREMENT<$50K 60 | 27,768.58 | CHUDAKOV | 1 | 1 |  | D | 07-024 | EUGENE C |  | 09-027 | 09-027 | 11-006 | 11-026 | 12-021F | 12-054 |  |  |  |  |  |  |  |  |  |  |  |  |  |  |  |  |  |  |
| 1552006 |  | Install Gas Handling Sys (TARGET) | 69d | 2013-05-24 | 2013-08-30 | 1552005 FS-51d | 169d | 149d |  | MECH TECH [208.9 h]; PROCUREMENT>$50K 69 NO ESCALATION FY14 | 9,580.15 | CHUDAKOV | 1 | 1 |  | D | 07-024 | EUGENE C |  | 09-027 | 09-027 | 11-006 | 11-026 | 12-021 | 12-054 |  |  |  |  | 13-014 |  |  |  |  |  |  |  |  |  |  |  |  |  |
| 1552028 |  | Prepare Procurements/Fabrication Packages solid target (TARGET) | 63d | 2013-05-31 | 2013-08-28 | 9-130M FS+163d | 189d | 0d |  | MECH TECH [240 h] | 11,006.4 | CHUDAKOV | 1 | 1 |  | D | 07-024 | EUGENE C |  | 09-027 | 09-027 | 11-006 | 11-026 | 12-021F | 12-054 |  |  |  |  |  |  |  |  |  |  |  |  |  |  |  |  |  |  |
| 1552040 |  | Assemble Target (TARGET) | 21d | 2013-08-02 | 2013-08-30 | 1552033, 1552020, 1552030, 9-130M FS+6d, 1552045 FS-170d, 1552027, 1552028b FS-190d, 1552035, 1552025, 1552006 FS-170d, 1552015 FS-60d, 1552005 FS-112d | 20d |  |  | MECH ENG [13.13 h]; MECH TECH [59.06 h] | 3,658.46 | CHUDAKOV | 1 | 1 |  | D | 07-024 | EUGENE C |  |  |  | 11-006 | 11-026 | 12-021 | 12-054 |  |  |  | 08-016 | 13-014 |  |  |  |  |  |  |  |  |  |  |  |  |  |
| 1552028b |  | Fabricate solid target (labor) | 2d | 2013-08-29 | 2013-08-30 | 1552028 | 189d | 169d |  | MECH TECH [10.16 h]; MECH DES [1.27 h]; MECH ENG [1.27 h] | 620.97 | CHUDAKOV | 1 | 1 |  | D | 07-024 | EUGENE C |  | 09-027 | 09-027 | 11-006 | 11-026 | 12-021F | 12-054 |  |  |  |  | 13-014 |  |  |  |  |  |  |  |  |  |  |  |  |  |
| 1552050 |  | Re-Baseline Actuals Adjustment | 1d | 2013-08-30 | 2013-08-30 | 9-130M FS+227d | 20d |  |  | PROCUREMENT>$50K 69 NO ESCALATION | 45,207.1 | CHUDAKOV | 1 | 1 |  |  |  | EUGENE C |  |  |  |  |  |  |  |  |  |  |  | 13-014 | ADJ |  |  |  |  |  |  |  |  |  |  |  |  |
| 2552001 |  | Prepare Procurements/Fabrication Packages FY13 (TARGET) | 20d | 2013-09-03 | 2013-09-30 | 9-130M FS+228d | 48d | 0d | 8/5 M-F w/JLAB Holidays ReBaseline | MECH DES [8 h]; MECH ENG [8 h] | 976.56 | CHUDAKOV | 1 | 1 | 2 | D | 07-024 | EUGENE C | 09-014 | 09-027 | 09-027 | 11-006 | 11-026 | 12-021F | 12-054F |  |  |  |  |  |  | 2552001 | S | 13-007F | PE | 13-015 | Review | PR |  |  |  |  |  |
| 2552005 |  | Proc Gas Handling Sys (TARGET) - Procurement | 50d | 2013-09-03 | 2013-11-11 | 9-130M FS+228d | 68d | 0d | 8/5 M-F w/JLAB Holidays ReBaseline | SUPPLIES & MATERIALS; PROCUREMENT>$50K 69 NO ESCALATION FY14 | 7,800 | CHUDAKOV | 1 | 1 |  | D | 07-024 | EUGENE C |  | 09-027 | 09-027 | 11-006 | 11-026 | 12-021 | 12-054 |  |  |  |  |  |  | 2552005 | D | 13-007F |  | 13-015 |  | PR | PE | EJ |  |  |  |
| 2552005a |  | Proc Gas Handling Sys (TARGET) - Expenses FY13 | 20d | 2013-09-03 | 2013-09-30 | 9-130M FS+228d | 68d | 0d | 8/5 M-F w/JLAB Holidays ReBaseline | SUPPLIES & MATERIALS | 3,632 | CHUDAKOV | 1 | 1 |  | D | 07-024 | EUGENE C |  | 09-027 | 09-027 | 11-006 | 11-026 | 12-021 | 12-054 |  |  |  |  |  |  | 2552005 | D | 13-007F |  | 13-015 |  | PR | PE | EJ |  |  |  |
| 2552008 |  | Manufacturing Drawings for gas System (Target) FY13 | 20d | 2013-09-03 | 2013-09-30 | 9-130M FS+228d | 96d | 0d | 8/5 M-F w/JLAB Holidays ReBaseline | MECH ENG [17.39 h]; MECH DES [19.88 h] | 2,246.63 | CHUDAKOV | 1 | 1 |  | D |  | EUGENE C |  |  |  |  |  |  |  |  |  |  |  |  |  | 2552008 | S | 13-007 | PE | 13-015 |  | PR |  |  |  |  |  |
| 2552010 |  | Proc Controls (TARGET) - Procurement | 65d | 2013-09-03 | 2013-12-04 | 9-130M FS+228d | 167d | 0d | 8/5 M-F w/JLAB Holidays ReBaseline | SUPPLIES & MATERIALS; PROCUREMENT>$50K 69 NO ESCALATION FY14 | 7,000 | CHUDAKOV | 1 | 1 |  | D | 07-024 | EUGENE C |  |  |  | 11-006 | 11-026 | 12-021 | 12-054 |  | 10-042 |  |  |  |  | 2552010 | D | 13-007F |  | 13-015 |  | PR | PE | PE |  |  |  |
| 2552010a |  | Proc Controls (TARGET) - Expenses FY13 | 20d | 2013-09-03 | 2013-09-30 | 9-130M FS+228d | 167d | 0d | 8/5 M-F w/JLAB Holidays ReBaseline | SUPPLIES & MATERIALS | 230.77 | CHUDAKOV | 1 | 1 |  | D | 07-024 | EUGENE C |  |  |  | 11-006 | 11-026 | 12-021 | 12-054 |  | 10-042 |  |  |  |  | 2552010 | D | 13-007F |  | 13-015 |  | PR | PE | PE |  |  |  |
| 2552015 |  | Fab Isolation Vac Pumping Sys (TARGET) (Previously Obligated) | 51d | 2013-09-03 | 2013-11-12 | 2552001 FS-30d, 2552001a FS-30d | 129d | 118d | 8/5 M-F w/JLAB Holidays ReBaseline | PROCUREMENT<$50K 60 NO ESCALATION FY14 | 11,509 | CHUDAKOV | 1 | 1 |  | D | 07-024 | EUGENE C |  | 09-027 | 09-027 | 11-006 | 11-026 | 12-021F | 12-054 |  |  |  |  |  |  | 2552015 | D | 13-007F |  | 13-015 |  | PR | PE | EJ | y | OB |  |
| 2552015a |  | Fab Isolation Vac Pumping Sys (TARGET) | 51d | 2013-09-03 | 2013-11-12 | 2552001 FS-30d, 2552001a FS-30d | 129d | 118d | 8/5 M-F w/JLAB Holidays ReBaseline | PROCUREMENT<$50K 60 NO ESCALATION FY14 | 14,887.99 | CHUDAKOV | 1 | 1 |  | D | 07-024 | EUGENE C |  | 09-027 | 09-027 | 11-006 | 11-026 | 12-021F | 12-054 |  |  |  |  |  |  | 2552015 | D | 13-007F |  | 13-015 |  | PR | PE | EJ |  |  |  |
| 2552023aa |  | Fab Target Cells (TARGET) FY13 | 20d | 2013-09-03 | 2013-09-30 | 9-130M FS+228d | 11d | 0d | 8/5 M-F w/JLAB Holidays ReBaseline | SUPPLIES & MATERIALS; MECH TECH [14.49 h] | 895.7 | CHUDAKOV | 1 | 1 |  | D | 07-024 | EUGENE C |  | 09-027 | 09-027 | 11-006 | 11-026 | 12-021 | 12-054F |  |  | 12-053 |  |  |  | 2552023aa | S | 13-007F | PE | 13-015 |  | PR |  | PE |  |  |  |
| 2552032 |  | Manufacturing Drawings for cryo system (Target) FY13 | 20d | 2013-09-03 | 2013-09-30 | 9-130M FS+228d | 100d | 0d | 8/5 M-F w/JLAB Holidays ReBaseline | MECH DES [28.8 h]; MECH ENG [32.4 h] | 3,776.11 | CHUDAKOV | 1 | 1 |  | D | 07-024 | EUGENE C |  | 09-027 | 09-027 | 11-006 | 11-026 | 12-021F | 12-054F |  | 10-042 |  |  |  |  | 2552032 | S | 13-007F | PE | 13-015 | Review | PR |  |  |  |  |  |
| 2552033 |  | Procure heat xchngr and cryo hardware | 20d | 2013-09-03 | 2013-09-30 | 2552032a FS-30d, 2552032 FS-30d | 100d | 89d | 8/5 M-F w/JLAB Holidays ReBaseline | PROCUREMENT<$50K 60 | 1,650 | CHUDAKOV | 1 | 1 |  | D | 07-024 | EUGENE C |  | 09-027 | 09-027 | 11-006 | 11-026 | 12-021 | 12-054 |  | 10-042 |  |  |  |  | 2552033 | D | 13-007F |  | 13-015 |  | PR | OB |  |  |  |  |
| 2552001a |  | Prepare Procurements/Fabrication Packages FY14 (TARGET) | 10d | 2013-10-01 | 2013-10-14 | 2552001, 9-130M FS+228d | 48d | 0d | 8/5 M-F w/JLAB Holidays ReBaseline | MECH DES [4 h]; MECH ENG [4 h] | 503.88 | CHUDAKOV | 1 | 1 | 2 | D | 07-024 | EUGENE C | 09-014 | 09-027 | 09-027 | 11-006 | 11-026 | 12-021F | 12-054F |  |  |  |  |  |  | 2552001 | S | 13-007F | PE | 13-015 | Review | PR |  |  |  |  | 14-001 |
| 2552005b |  | Proc Gas Handling Sys (TARGET) - Expenses FY14 | 30d | 2013-10-01 | 2013-11-11 | 2552005a, 9-130M FS+228d | 68d | 0d | 8/5 M-F w/JLAB Holidays ReBaseline | SUPPLIES & MATERIALS | 5,621.79 | CHUDAKOV | 1 | 1 |  | D | 07-024 | EUGENE C |  | 09-027 | 09-027 | 11-006 | 11-026 | 12-021 | 12-054 |  |  |  |  |  |  | 2552005 | D | 13-007F |  | 13-015 |  | PR | PE | EJ |  |  | 14-001 |
| 2552008a |  | Manufacturing Drawings for gas System (Target) FY14 | 46d | 2013-10-01 | 2013-12-05 | 2552008, 9-130M FS+228d | 96d | 17d | 8/5 M-F w/JLAB Holidays ReBaseline | MECH ENG [40.01 h]; MECH DES [45.72 h] | 5,332.92 | CHUDAKOV | 1 | 1 |  | D |  | EUGENE C |  |  |  |  |  |  |  |  |  |  |  |  |  | 2552008 | S | 13-007 | PE | 13-015 |  | PR |  |  |  |  | 14-001 |
| 2552010b |  | Proc Controls (TARGET) - Expenses FY14 | 45d | 2013-10-01 | 2013-12-04 | 2552010a, 9-130M FS+228d | 167d | 0d | 8/5 M-F w/JLAB Holidays ReBaseline | SUPPLIES & MATERIALS | 535.79 | CHUDAKOV | 1 | 1 |  | D | 07-024 | EUGENE C |  |  |  | 11-006 | 11-026 | 12-021 | 12-054 |  | 10-042 |  |  |  |  | 2552010 | D | 13-007F |  | 13-015 |  | PR | PE | PE |  |  | 14-001 |
| 2552023aaa |  | Fab Target Cells (TARGET) FY14 | 89d | 2013-10-01 | 2014-02-17 | 9-130M FS+228d, 2552023aa | 11d | 0d | 8/5 M-F w/JLAB Holidays ReBaseline | SUPPLIES & MATERIALS; MECH TECH [64.46 h] | 4,111.87 | CHUDAKOV | 1 | 1 |  | D | 07-024 | EUGENE C |  | 09-027 | 09-027 | 11-006 | 11-026 | 12-021 | 12-054F |  |  | 12-053 |  |  |  | 2552023aa | S | 13-007F | PE | 13-015 |  | PR |  | PE |  |  | 14-001 |
| 2552032a |  | Manufacturing Drawings for cryo system (Target) FY14 | 10d | 2013-10-01 | 2013-10-14 | 2552032, 9-130M FS+228d | 100d | 0d | 8/5 M-F w/JLAB Holidays ReBaseline | MECH DES [14.4 h]; MECH ENG [16.2 h] | 1,948.37 | CHUDAKOV | 1 | 1 |  | D | 07-024 | EUGENE C |  | 09-027 | 09-027 | 11-006 | 11-026 | 12-021F | 12-054F |  | 10-042 |  |  |  |  | 2552032 | S | 13-007F | PE | 13-015 | Review | PR |  |  |  |  | 14-001 |
| 2552012 |  | Program Target Controls | 52d | 2013-10-07 | 2013-12-19 | 2552010b FS-41d, 2552010 FS-41d, 2552010a FS-41d | 214d | 203d | 8/5 M-F w/JLAB Holidays ReBaseline | COMP SCIENT [160 h] | 11,179.2 | CHUDAKOV | 1 | 1 |  | D | 07-024 | EUGENE C |  |  |  | 11-006 | 11-026 | 12-021 | 12-054F |  |  |  | 08-016 |  |  | 2552012 | S | 13-007 | EJ | 13-015 |  | PR |  |  |  |  | 14-001 |
| 2552018a |  | Fab Outer Vac/Scattering Chamb (TARGET) | 38d | 2013-10-15 | 2013-12-09 | 2552001a, 2552001 | 52d | 41d | 8/5 M-F w/JLAB Holidays ReBaseline | SUPPLIES & MATERIALS; MECH ENG [40 h]; MECH TECH [240 h] | 25,556.23 | CHUDAKOV | 1 | 1 |  | D | 07-024 | EUGENE C |  | 09-027 | 09-027 | 11-006 | 11-026 | 12-021 | 12-054F |  |  |  |  |  |  | 2552018a | S | 13-007F | PE | 13-015 | Review | PR |  | EJ |  |  | 14-001 |
| 2552035 |  | Fab Positioning/Mounting Sys (TARGET) | 42d | 2013-11-01 | 2014-01-13 | 2552001, 2552001a, 9-140M FS+23d | 35d | 24d | 8/5 M-F w/JLAB Holidays ReBaseline | PROCUREMENT<$50K 60; SUPPLIES & MATERIALS | 16,716.78 | CHUDAKOV | 1 | 1 |  | D | 07-024 | EUGENE C |  | 09-027 | 09-027 | 11-006 | 11-026 | 12-021 | 12-054 |  |  |  |  |  |  | 2552035 | D | 13-007F |  | 13-015 |  | PR | PE | EJ |  |  | 14-001 |
| 2552006 |  | Install Gas Handling Sys (TARGET) | 86d | 2014-01-10 | 2014-05-12 | 2552005a FS+33d, 2552005b FS+33d, 2552008, 2552008a, 2552005 FS+33d | 79d | 68d | 8/5 M-F w/JLAB Holidays ReBaseline | MECH TECH [329.6 h]; SUPPLIES & MATERIALS; MECH ENG [20 h]; MECH DES [16 h] | 18,426.82 | CHUDAKOV | 1 | 1 |  | D | 07-024 | EUGENE C |  | 09-027 | 09-027 | 11-006 | 11-026 | 12-021 | 12-054 |  |  |  |  |  |  | 2552006 | S | 13-007 | EJ | 13-015 |  | PR |  | EJ |  |  | 14-001 |
| 2552007 |  | Install Gas Tank (TARGET) | 18d | 2014-01-10 | 2014-02-05 | 2552001a, 9-140M FS+63d, 2552001, 2552005 FS-16d, 2552005a FS-16d, 2552005b FS-16d | 19d | 8d | 8/5 M-F w/JLAB Holidays ReBaseline | PROCUREMENT>$50K 69 | 19,090.15 | CHUDAKOV | 1 | 1 |  | D | 07-024 | EUGENE C |  | 09-027 | 09-027 | 11-006 | 11-026 | 12-021 | 12-054 |  |  |  |  |  |  | 2552007 | S | 13-007 |  | 13-015 |  | PR | PE |  |  |  | 14-001 |
| 2552028 |  | Prepare Procurements/Fabrication Packages solid target (TARGET) | 42d | 2014-02-03 | 2014-04-01 | 9-140M FS+78d | 131d | 0d | 8/5 M-F w/JLAB Holidays ReBaseline | MECH TECH [240 h]; MECH ENG [100 h]; MECH DES [164 h] | 27,237 | CHUDAKOV | 1 | 1 |  | D | 07-024 | EUGENE C |  | 09-027 | 09-027 | 11-006 | 11-026 | 12-021F | 12-054 |  |  |  |  |  |  | 2552028 | S | 13-007F | PE | 13-015 |  | PR |  |  |  |  | 14-001 |
| 2552040 |  | Assemble Target (TARGET) | 128d | 2014-02-18 | 2014-08-18 | 2552018a, 2552010b FS-112d, 2552035, 2552006 FS-170d, 2552015 FS-60d, 2552007, 2552010 FS-112d, 2552028a FS-190d, 2552028b FS-190d, 2552015a FS-60d, 2552010a FS-112d, 2552023aaa, 2552023aa, 2552033, 2552012 FS-170d | 11d | 0d | 8/5 M-F w/JLAB Holidays ReBaseline | MECH ENG [80 h]; MECH TECH [360 h] | 23,008.8 | CHUDAKOV | 1 | 1 |  | D | 07-024 | EUGENE C |  |  |  | 11-006 | 11-026 | 12-021 | 12-054 |  |  |  | 08-016 |  |  | 2552040 | S | 13-007F | EJ | 13-015 |  | PR |  |  |  |  | 14-001 |
| 2552028a |  | Fabricate solid target (proc) | 38d | 2014-04-03 | 2014-05-27 | 2552028 FS+1d | 131d | 120d | 8/5 M-F w/JLAB Holidays ReBaseline | SUPPLIES & MATERIALS | 15,272.12 | CHUDAKOV | 1 | 1 |  | D | 07-024 | EUGENE C |  | 09-027 | 09-027 | 11-006 | 11-026 | 12-021F | 12-054 |  |  |  |  |  |  | 2552028a | D | 13-007F |  | 13-015 |  | PR |  | EJ |  |  | 14-001 |
| 2552028b |  | Fabricate solid target (labor) | 38d | 2014-04-03 | 2014-05-27 | 2552028 FS+1d | 131d | 120d | 8/5 M-F w/JLAB Holidays ReBaseline | MECH TECH [320 h]; MECH DES [40 h]; MECH ENG [40 h] | 20,181.2 | CHUDAKOV | 1 | 1 |  | D | 07-024 | EUGENE C |  | 09-027 | 09-027 | 11-006 | 11-026 | 12-021F | 12-054 |  |  |  |  |  |  | 2552028b | U | 13-007F | EJ | 13-015 |  | PR |  |  |  |  | 14-001 |

| ID | WBS | Activity | Duration | Start | Finish | Predecessors | Total float | Free float | Calendar | Resources | Cost | RESP - Responsibility | STRT%COMP for CM EVM | FNSH%COMP for CM EVM | HALL D Related Milestones | CR 07-024 | CAM RESPONSIBLE | CR 11-006 | CR 11-026 | 12 GeV 2nd level Critical Path | CR 09-014 | CR 09-027 | CR 09-027 Repair | CR 12-021 | CR 11-004 | CR 12-054 | CR 08-016 | CR 09-012 | CR 12-055 | CR 12-053 | CR 13-014 | ReBaseline Actuals Adjustment | Original Activity ID Rebaseline | EVMS Reporting Codes | BOE Labor | CR 13-015 | Post Rebaseline | BOE Procurement | Over Under Fixed | CR 13-007 | Obligated Prior to Rebaseline | CR 14-001 |
| --- | --- | --- | --- | --- | --- | --- | --- | --- | --- | --- | --- | --- | --- | --- | --- | --- | --- | --- | --- | --- | --- | --- | --- | --- | --- | --- | --- | --- | --- | --- | --- | --- | --- | --- | --- | --- | --- | --- | --- | --- | --- | --- |
|  | 3 | **1.5.5.3 BEAMLINE COMPONENTS** |  | 2009-10-01 | 2015-04-01 |  |  |  |  |  |  |  |  |  |  |  |  |  |  |  |  |  |  |  |  |  |  |  |  |  |  |  |  |  |  |  |  |  |  |  |  |  |
| 1553010E |  | FY10 Travel (BL Compnts) | 248d | 2009-10-01 | 2010-09-30 | 9-100M | 20d | 0d |  | TRAVEL | 879.02 | CHUDAKOV | 1 | 1 | D | 07-024 | EUGENE C | 11-006 | 11-026 |  |  |  |  |  |  |  |  |  |  |  |  |  |  |  |  |  |  |  |  |  |  |  |
| 1553001 |  | Engineering Support for Obtaining/Tstng Pair Spectrmtr Mag (BL Compnts) | 65d | 2010-10-01 | 2011-01-11 | 9-110M | 678d | 0d |  | MECH ENG [80 h]; MECH DES [240 h] | 16,639.2 | CHUDAKOV | 1 | 1 | D | 07-024 | EUGENE C |  | 11-026 | 2 | 09-014 | 09-027 | 09-027 | 12-021F |  |  |  |  |  |  |  |  |  |  |  |  |  |  |  |  |  |  |
| 1553011E |  | FY11 Travel (BL Compnts) | 248d | 2010-10-01 | 2011-09-30 | 1553010E | 20d | 0d |  | TRAVEL | 907.06 | CHUDAKOV | 1 | 1 | D | 07-024 | EUGENE C | 11-006 | 11-026 |  |  |  |  |  |  |  |  |  |  |  |  |  |  |  |  |  |  |  |  |  |  |  |
| 1553030 |  | Obtain Surplus Mag (BL Compnts) | 65d | 2010-10-01 | 2011-01-11 | 1553001 FS-65d, 9-110M | 678d |  |  | SCIENTIST [160 h] | 10,948.8 | CHUDAKOV | 1 | 1 | D |  | EUGENE C |  | 11-026 |  | 09-014 |  |  | 12-021F |  |  |  |  |  |  |  |  |  |  |  |  |  |  |  |  |  |  |
| 1553001a |  | Prepare Procurements Packages 2011 (BL Compnts) | 188d | 2011-01-05 | 2011-09-30 | 9-110M FS+60d | 383d | 78d |  | MECH DES [320 h]; MECH ENG [160 h] | 25,809.6 | CHUDAKOV | 1 | 1 | D | 07-024 | EUGENE C | 11-006 | 11-026 | 2 | 09-014 | 09-027 | 09-027 |  | 11-004 |  |  |  |  |  |  |  |  |  |  |  |  |  |  |  |  |  |
| 1553100 |  | Prepare Environment for Sweep Magnets (BL Compnts) | 50d | 2011-03-18 | 2011-05-26 | 9-110M FS+110d | 552d | 119d |  | MECH TECH [400 h] | 17,228 | CHUDAKOV | 1 | 1 | D |  | EUGENE C |  | 11-026 |  |  |  |  | 12-021F | 11-004 |  |  |  |  |  |  |  |  |  |  |  |  |  |  |  |  |  |
| 1553031 |  | Develop magnet gap modification | 44d | 2011-08-01 | 2011-09-30 | 9-110M FS+204d | 349d | 0d |  | MECH DES [320 h]; MECH ENG [320 h] | 36,681.6 | CHUDAKOV | 1 | 1 | D |  | EUGENE C | 11-006 | 11-026 |  | 09-014 |  |  | 12-021F |  |  |  |  |  |  |  |  |  |  |  |  |  |  |  |  |  |  |
| 1553012E |  | FY12 Travel (BL Compnts) | 247d | 2011-10-03 | 2012-09-28 | 1553011E | 20d | 0d |  | TRAVEL | 936 | CHUDAKOV | 1 | 1 | D | 07-024 | EUGENE C | 11-006 | 11-026 |  |  |  |  |  |  |  |  |  |  |  |  |  |  |  |  |  |  |  |  |  |  |  |
| 1553032 |  | Fabricate magnet gap modification | 81d | 2011-10-03 | 2012-02-03 | 1553031 | 349d | 63d |  | PROCUREMENT<$50K 60 | 12,382.8 | CHUDAKOV | 1 | 1 | D |  | EUGENE C | 11-006 | 11-026 |  | 09-014 |  |  | 12-021F |  |  |  |  |  |  |  |  |  |  |  |  |  |  |  |  |  |  |
| 1553048 |  | Proc Pair convertor (BL Compnts) Labor Original | 18d | 2012-01-05 | 2012-01-31 | 9-120M FS+60d | 270d | 0d |  | MECH DES [33.23 h]; MECH ENG [11.08 h] | 2,377.62 | CHUDAKOV | 1 | 1 | D |  | EUGENE C | 11-006 | 11-026 |  |  |  |  | 12-021 |  | 12-054F |  |  |  |  |  |  |  |  |  |  |  |  |  |  |  |  |
| 1553065 |  | Proc Active Collimator Compnts (BL Compnts) | 130d | 2012-01-05 | 2012-07-10 | 9-120M FS+60d | 358d | 0d |  | PROCUREMENT<$50K 60 | 11,700.06 | CHUDAKOV | 1 | 1 | D |  | EUGENE C |  | 11-026 |  |  |  |  |  |  |  |  |  |  |  |  |  |  |  |  |  |  |  |  |  |  |  |
| 1553080 |  | Proc Passive Collimator Sys (BL Compnts) | 130d | 2012-01-05 | 2012-07-10 | 9-120M FS+60d | 265d | 0d |  | PROCUREMENT>$50K 69; PROCUREMENT<$50K 60 | 70,200.35 | CHUDAKOV | 1 | 1 | D |  | EUGENE C |  | 11-026 |  |  |  |  |  |  |  |  |  |  |  |  |  |  |  |  |  |  |  |  |  |  |  |
| 1553085 |  | Design Primary Collimator Support (BL Compnts) | 55d | 2012-01-05 | 2012-03-23 | 9-120M FS+60d | 393d | 0d |  | MECH DES [440 h] | 21,194.8 | CHUDAKOV | 1 | 1 | D |  | EUGENE C |  | 11-026 |  |  |  |  |  |  |  |  |  |  |  |  |  |  |  |  |  |  |  |  |  |  |  |
| 1553002 |  | Prepare Procurements Packages 2012 (BL Compnts) | 112d | 2012-02-01 | 2012-07-10 | 1553001a, 9-120M FS+78d | 305d |  |  | MECH DES [480 h]; MECH ENG [240 h] | 39,950.4 | CHUDAKOV | 1 | 1 | D | 07-024 | EUGENE C | 11-006 | 11-026 | 2 | 09-014 | 09-027 | 09-027 |  | 11-004 |  |  |  |  |  |  |  |  |  |  |  |  |  |  |  |  |  |
| 1553048a |  | Proc Pair convertor (BL Compnts) Labor Revised 2012 ETC | 167d | 2012-02-03 | 2012-09-28 | 1553048 FS+2d | 270d | 250d |  | MECH DES [206.77 h]; MECH ENG [68.92 h] | 14,792.78 | CHUDAKOV | 1 | 1 | D |  | EUGENE C | 11-006 | 11-026 |  |  |  |  | 12-021 |  | 12-054F |  |  |  |  |  |  |  |  |  |  |  |  |  |  |  |  |
| 1553036 |  | Build Pair Spectrometer Vacuum Box Labor (BL Compnts) Labor | 59d | 2012-02-28 | 2012-05-18 | 9-120M FS+96d | 238d | 0d |  | MECH TECH [120 h] | 5,332.8 | CHUDAKOV | 1 | 1 | D |  | EUGENE C | 11-006 | 11-026 |  | 09-014 |  |  | 12-021 |  |  |  |  |  |  |  |  |  |  |  |  |  |  |  |  |  |  |
| 1553034 |  | Develop Pair Spec magnet support | 44d | 2012-03-05 | 2012-05-03 | 9-120M FS+100d | 267d | 0d |  | MECH ENG [85.09 h]; MECH DES [102.11 h] | 10,885.16 | CHUDAKOV | 1 | 1 | D |  | EUGENE C | 11-006 | 11-026 |  | 09-014 |  |  | 12-021 |  |  |  |  |  |  |  |  |  |  |  |  |  |  |  |  |  |  |
| 1553090 |  | Fabricate Collimator Support (BL Compnts) | 40d | 2012-03-26 | 2012-05-18 | 1553085 | 393d | 35d |  | PROCUREMENT<$50K 60 | 17,550.09 | CHUDAKOV | 1 | 1 | D |  | EUGENE C |  | 11-026 |  |  |  |  |  |  |  |  |  |  |  |  |  |  |  |  |  |  |  |  |  |  |  |
| 1553035 |  | Proc Pair Spectrometer Mag Pwr Supply (BL Compnts) | 206d | 2012-04-03 | 2013-01-31 | 9-120M FS+121d | 168d |  |  | PROCUREMENT<$50K 60 NO ESCALATION FY13 | 48,297.85 | CHUDAKOV | 1 | 1 | D |  | EUGENE C |  | 11-026 |  | 09-014 |  |  | 12-021 |  |  | 08-016 | 09-012 |  |  |  |  |  |  |  |  |  |  |  |  |  |  |
| 1553038 |  | Build Pair Spectrometer Vacuum Box (BL Compnts) | 59d | 2012-04-09 | 2012-07-02 | 1553036 FS-30d | 238d | 110d |  | PROCUREMENT<$50K 60 | 26,500 | CHUDAKOV | 1 | 1 | D |  | EUGENE C | 11-006 | 11-026 |  | 09-014 |  |  | 12-021 |  |  |  |  |  |  |  |  |  |  |  |  |  |  |  |  |  |  |
| 1553033 |  | Install magnet gap modification | 65d | 2012-05-04 | 2012-08-06 | 9-120M FS+144d, 1553032 | 286d |  |  | MECH TECH [320 h]; MECH ENG [80 h]; MECH DES [40 h] | 21,757.2 | CHUDAKOV | 1 | 1 | D |  | EUGENE C | 11-006 | 11-026 |  | 09-014 |  |  | 12-021 |  |  |  |  |  |  |  |  |  |  |  |  |  |  |  |  |  |  |
| 1553034a |  | Procure Pair Spec magnet support | 84d | 2012-05-04 | 2012-08-31 | 1553034 | 267d |  |  | PROCUREMENT<$50K 60 | 23,500 | CHUDAKOV | 1 | 1 | D |  | EUGENE C | 11-006 | 11-026 |  | 09-014 |  |  | 12-021 |  |  |  |  |  |  |  |  |  |  |  |  |  |  |  |  |  |  |
| 1553040 |  | Proc Pair Spectrometer Detctr's (BL Compnts) Part A | 162d | 2012-05-04 | 2012-12-31 | 9-120M FS+144d | 128d | 0d |  | PROCUREMENT<$50K 60 NO ESCALATION FY13 | 56,000 | CHUDAKOV | 1 | 1 | D |  | EUGENE C |  | 11-026 |  |  |  |  | 12-021 |  |  |  |  | 12-055 |  |  |  |  |  |  |  |  |  |  |  |  |  |
| 1553040a |  | Proc Pair Spectrometer Detctr's (BL Compnts) Part B | 162d | 2012-05-04 | 2012-12-31 | 9-120M FS+144d | 128d | 0d |  | PROCUREMENT<$50K 60 NO ESCALATION FY13 | 9,000 | CHUDAKOV | 1 | 1 | D |  | EUGENE C |  | 11-026 |  |  |  |  | 12-021 |  |  |  |  | 12-055 |  |  |  |  |  |  |  |  |  |  |  |  |  |
| 1553095 |  | Purchase Lead for Cave Exit Wall (BL Compnts) | 63d | 2012-05-07 | 2012-08-03 | 9-120M FS+145d | 287d |  |  | PROCUREMENT<$50K 60 | 58,500.29 | CHUDAKOV | 1 | 1 | D |  | EUGENE C | 11-006 | 11-026 |  |  |  |  | 12-021F |  |  |  |  |  |  |  |  |  |  |  |  |  |  |  |  |  |  |
| 1553105 |  | Purchase Slow Control Crate (BL Compnts) | 65d | 2012-06-06 | 2012-09-05 | 9-120M FS+165d | 203d | 178d |  | PROCUREMENT<$50K 60 | 14,010.82 | CHUDAKOV | 1 | 1 | D | 07-024 | EUGENE C | 11-006 | 11-026 |  |  |  |  |  | 11-004 |  |  |  |  |  |  |  |  |  |  |  |  |  |  |  |  |  |
| 1553070 |  | Assemble Active Collimator (BL Compnts) FY12 | 57d | 2012-07-11 | 2012-09-28 | 1553065, 1553090 | 358d | 0d |  | PD UNIV STUDNT [280.62 h] | 2,994.22 | CHUDAKOV | 1 | 1 | D |  | EUGENE C |  | 11-026 |  |  |  |  |  |  |  |  |  |  | 12-053 |  |  |  |  |  |  |  |  |  |  |  |  |
| 1553072 |  | Program & test Collimator Table (BL Components) FY12 | 57d | 2012-07-11 | 2012-09-28 | 1553080 | 378d | 0d |  | VISTNG USERS [111.93 h]; MECH DES [68.4 h]; CONTRB UNIV LBR [37.31 h]; MECH ENG [24.87 h] | 7,202.32 | CHUDAKOV | 1 | 1 | D |  | EUGENE C | 11-006 | 11-026 |  | 09-014 |  |  |  |  |  |  |  |  | 12-053 |  |  |  |  |  |  |  |  |  |  |  |  |
| 1553013E |  | FY13 Travel (BL Compnts) | 228d | 2012-10-01 | 2013-08-30 | 1553012E | 20d |  |  | TRAVEL | 887.97 | CHUDAKOV | 1 | 1 | D | 07-024 | EUGENE C | 11-006 | 11-026 |  |  |  |  |  |  |  |  |  |  |  | 13-014 |  |  |  |  |  |  |  |  |  |  |  |
| 1553070a |  | Assemble Active Collimator (BL Compnts) FY13 | 73d | 2012-10-01 | 2013-01-22 | 1553065, 1553090, 1553070 | 358d | 0d |  | PD UNIV STUDNT [359.38 h] | 3,956.77 | CHUDAKOV | 1 | 1 | D |  | EUGENE C |  | 11-026 |  |  |  |  |  |  |  |  |  |  | 12-053 |  |  |  |  |  |  |  |  |  |  |  |  |
| 1553072a |  | Program & test Collimator Table (BL Components) FY13 | 53d | 2012-10-01 | 2012-12-14 | 1553072 | 378d | 20d |  | VISTNG USERS [104.07 h]; MECH DES [63.6 h]; CONTRB UNIV LBR [34.69 h]; MECH ENG [23.13 h] | 6,911.45 | CHUDAKOV | 1 | 1 | D |  | EUGENE C | 11-006 | 11-026 |  | 09-014 |  |  |  |  |  |  |  |  | 12-053 |  |  |  |  |  |  |  |  |  |  |  |  |
| 1553015 |  | Proc Goniometer (BL Compnts) | 123d | 2012-11-26 | 2013-05-28 | 9-130M FS+38d | 25d | 0d |  | PROCUREMENT>$50K 69; PROCUREMENT<$50K 60 | 169,026.08 | CHUDAKOV | 1 | 1 | D |  | EUGENE C | 11-006 | 11-026 |  |  |  |  | 12-021 | 11-004 | 12-054 |  |  |  |  |  |  |  |  |  |  |  |  |  |  |  |  |
| 1553045 |  | Manufacture, Mount and Test Pair Spectrometer Detctr's (BL Compnts) | 73d | 2012-12-07 | 2013-03-29 | 1553040 FS-12d, 1553040a FS-12d, 1553038, 1553036 | 128d |  |  | MECH DES [320 h]; MECH ENG [200 h]; MECH TECH [320 h] | 45,054.4 | CHUDAKOV | 1 | 1 | D |  | EUGENE C | 11-006 | 11-026 |  |  |  |  | 12-021 |  |  |  |  |  |  |  |  |  |  |  |  |  |  |  |  |  |  |
| 1553017 |  | Procure vacuum gauges and valves for tagger beamline | 59d | 2013-01-03 | 2013-03-28 | 9-130M FS+60d | 129d |  |  | PROCUREMENT<$50K 60 | 12,898.75 | CHUDAKOV | 1 | 1 | D |  | EUGENE C | 11-006 | 11-026 |  |  |  |  | 12-021 | 11-004 | 12-054 |  |  |  |  |  |  |  |  |  |  |  |  |  |  |  |  |
| 1553075 |  | Test Active Collimator (BL Compnts) | 65d | 2013-01-23 | 2013-04-24 | 1553070, 1553070a, 1553072a | 358d |  |  | PD UNIV STUDNT [640 h]; CONTRB UNIV LBR [640 h] | 7,046.4 | CHUDAKOV | 1 | 1 | D |  | EUGENE C |  | 11-026 |  |  |  |  |  |  |  |  |  |  |  |  |  |  |  |  |  |  |  |  |  |  |  |
| 1553060 |  | Proc Roughing Pump (BL Compnts) | 130d | 2013-02-08 | 2013-08-13 | 9-130M FS+85d | 33d |  |  | PROCUREMENT<$50K 60 | 6,036.66 | CHUDAKOV | 1 | 1 | D |  | EUGENE C |  | 11-026 |  |  |  |  |  |  | 12-054 |  |  |  |  |  |  |  |  |  |  |  |  |  |  |  |  |
| 1553050 |  | Proc Pair convertor (BL Compnts) | 59d | 2013-04-08 | 2013-06-28 | 9-130M FS+125d, 1553048a FS-125d, 1553048 FS-130d | 20d | 0d |  | PROCUREMENT<$50K 60 | 17,026.35 | CHUDAKOV | 1 | 1 | D |  | EUGENE C | 11-006 | 11-026 |  |  |  |  | 12-021 |  | 12-054 |  |  |  |  |  |  |  |  |  |  |  |  |  |  |  |  |
| 1553020 |  | Write Control Software for Goniometer (BL Compnts) | 62d | 2013-05-29 | 2013-08-23 | 1553015, 1553105 | 25d |  |  | SCIENTIST [360 h] | 26,229.6 | CHUDAKOV | 1 | 1 | D |  | EUGENE C | 11-006 | 11-026 |  |  |  |  | 12-021 | 11-004 | 12-054 |  |  |  |  |  |  |  |  |  |  |  |  |  |  |  |  |
| 1553055 |  | Assemble and Test Pair convertor (BL Compnts) | 36d | 2013-07-12 | 2013-08-30 | 1553050 FS+8d | 20d |  |  | MECH TECH [90 h]; MECH ENG [45 h]; MECH DES [90 h]; SCIENTIST [225 h] | 28,251 | CHUDAKOV | 1 | 1 | D |  | EUGENE C | 11-006 | 11-026 |  |  |  |  | 12-021 |  | 12-054 |  |  |  |  | 13-014 |  |  |  |  |  |  |  |  |  |  |  |
| 1553110 |  | Re-Baseline Actuals Adjustment | 1d | 2013-08-30 | 2013-08-30 | 9-130M FS+227d | 20d |  |  | PROCUREMENT>$50K 69 NO ESCALATION | -105,527.35 | CHUDAKOV | 1 | 1 |  |  | EUGENE C |  |  |  |  |  |  |  |  |  |  |  |  |  | 13-014 | ADJ |  |  |  |  |  |  |  |  |  |  |
| 2553011 |  | Diamond contractor and procurements support (BL Compnts) FY13 | 20d | 2013-09-03 | 2013-09-30 | 9-130M FS+228d | 0d |  | 8/5 M-F w/JLAB Holidays ReBaseline | SCIENTIST [7.19 h]; MECH ENG [2.4 h] | 697.53 | CHUDAKOV | 1 | 1 | D |  | EUGENE C | 11-006 | 11-026 |  |  |  |  | 12-021 |  | 12-054 |  |  |  |  |  |  | 2553011 | E | PE | 13-015 | PR |  |  |  |  |  |
| 2553017 |  | Procure vacuum gauges and valves for tagger beamline | 36d | 2013-09-03 | 2013-10-22 | 9-130M FS+228d | 208d | 0d | 8/5 M-F w/JLAB Holidays ReBaseline | PROCUREMENT<$50K 60 NO ESCALATION FY14 | 3,224.69 | CHUDAKOV | 1 | 1 | D |  | EUGENE C | 11-006 | 11-026 |  |  |  |  | 12-021 | 11-004 | 12-054 |  |  |  |  |  |  | 2553017 | D |  | 13-015 | PR | CP |  |  |  |  |
| 2553035 |  | Proc Pair Spectrometer Mag Pwr Supply (BL Compnts) | 20d | 2013-09-03 | 2013-09-30 | 9-130M FS+228d | 36d | 0d | 8/5 M-F w/JLAB Holidays ReBaseline | PROCUREMENT>$50K 69; PROCUREMENT<$50K 60 | 74,300 | CHUDAKOV | 1 | 1 | D |  | EUGENE C |  | 11-026 |  | 09-014 |  |  | 12-021 |  |  | 08-016 | 09-012 |  |  |  |  | 2553035 | D |  | 13-015 | PR | OB | y | 13-007F | OB |  |
| 2553036 |  | Proc Parts for Pair Spectrometer | 20d | 2013-09-03 | 2013-09-30 | 9-130M FS+228d | 155d | 0d | 8/5 M-F w/JLAB Holidays ReBaseline | PROCUREMENT<$50K 60 | 1,360 | CHUDAKOV | 1 | 1 | D |  | EUGENE C |  | 11-026 |  | 09-014 |  |  | 12-021 |  |  | 08-016 | 09-012 |  |  |  |  | 2553036 | D |  | 13-015 | PR | VQ |  | 13-007F |  |  |
| 2553041 |  | Build PS low granularity Support Frame | 21d | 2013-09-03 | 2013-10-01 | 2553036 FS-20d | 155d | 0d | 8/5 M-F w/JLAB Holidays ReBaseline | PROCUREMENT<$50K 60 NO ESCALATION FY14 | 620 | CHUDAKOV | 1 | 1 | D |  | EUGENE C |  | 11-026 |  |  |  |  | 12-021 |  |  |  |  | 12-055 |  |  |  | 2553041 | D |  | 13-015 | PR | PE |  | 13-007F |  |  |
| 2553042 |  | Fabricate PS High Granularity Counters | 20d | 2013-09-03 | 2013-09-30 | 9-130M FS+228d | 213d | 0d | 8/5 M-F w/JLAB Holidays ReBaseline | MECH TECH [128 h]; SCIENTIST [24 h] | 7,618.72 | CHUDAKOV | 1 | 1 | D |  | EUGENE C |  | 11-026 |  |  |  |  | 12-021 |  |  |  |  | 12-055 |  |  |  | 2553042 | U | PE | 13-015 | PR |  |  | 13-007F |  |  |
| 2553050 |  | Proc Pair convertor insertion device (BL Compnts) (Previously Obligated) | 51d | 2013-09-03 | 2013-11-12 | 9-130M FS+228d | 108d | 0d | 8/5 M-F w/JLAB Holidays ReBaseline | PROCUREMENT<$50K 60 NO ESCALATION FY14 | 13,324.8 | CHUDAKOV | 1 | 1 | D |  | EUGENE C | 11-006 | 11-026 |  |  |  |  | 12-021 |  | 12-054 |  |  |  |  |  |  | 2553050 | D |  | 13-015 | PR | PE | y | 13-007F | OB |  |
| 2553052 |  | Proc Pair convertor insertion device (BL Compnts) | 51d | 2013-09-03 | 2013-11-12 | 9-130M FS+228d | 108d | 0d | 8/5 M-F w/JLAB Holidays ReBaseline | PROCUREMENT<$50K 60 NO ESCALATION FY14 | 3,702.35 | CHUDAKOV | 1 | 1 | D |  | EUGENE C | 11-006 | 11-026 |  |  |  |  | 12-021 |  | 12-054 |  |  |  |  |  |  | 2553050 | D |  | 13-015 | PR | PE |  | 13-007F |  |  |
| 2553062 |  | UConn Contract - Procure Readout Electronics for Active Collimator | 40d | 2013-09-03 | 2013-10-28 | 9-130M FS+228d | 150d | 0d | 8/5 M-F w/JLAB Holidays ReBaseline | PROCUREMENT<$50K 60 NO ESCALATION; PROCUREMENT>$50K 69 NO ESCALATION | 6,000.18 | CHUDAKOV | 1 | 1 | D |  | EUGENE C |  | 11-026 |  |  |  |  |  |  | 12-054 |  |  |  |  |  |  | 2553062 | D |  | 13-015 | PR | OB | y |  | OB |  |
| 2553063 |  | UConn Contract - Assembly and Test of Active Collimator | 77d | 2013-09-03 | 2013-12-20 | 2553062 FS-40d | 150d | 0d | 8/5 M-F w/JLAB Holidays ReBaseline | PROCUREMENT>$50K 69 NO ESCALATION | 6,192 | CHUDAKOV | 1 | 1 | D |  | EUGENE C |  | 11-026 |  |  |  |  |  |  | 12-054 |  |  |  |  |  |  | 2553063 | D |  | 13-015 | PR | OB | y |  | OB |  |
| 2553064 |  | UConn Contract - Delivery of Active Collimator to JLab | 77d | 2013-09-03 | 2013-12-20 | 2553063 FS-77d | 150d | 110d | 8/5 M-F w/JLAB Holidays ReBaseline | PROCUREMENT>$50K 69 NO ESCALATION | 679 | CHUDAKOV | 1 | 1 | D |  | EUGENE C |  | 11-026 |  |  |  |  |  |  | 12-054 |  |  |  |  |  |  | 2553064 | D |  | 13-015 | PR | OB | y |  | OB |  |
| 2553072a |  | Program & test Collimator Table (BL Components) FY13 | 20d | 2013-09-03 | 2013-09-30 | 9-130M FS+228d | 156d | 0d | 8/5 M-F w/JLAB Holidays ReBaseline | SCIENTIST [22.53 h]; ELEC ENG [11.27 h] | 2,462.11 | CHUDAKOV | 1 | 1 | D |  | EUGENE C | 11-006 | 11-026 |  | 09-014 |  |  |  |  |  |  |  |  | 12-053 |  |  | 2553072a | S | EJ | 13-015 | PR |  |  |  |  |  |
| 2553080 |  | Proc Active Collimator Control Equipment (HallD) | 205d | 2013-09-03 | 2014-07-02 | 9-130M FS+228d | 22d | 2d | 8/5 M-F w/JLAB Holidays ReBaseline | PROCUREMENT<$50K 60 NO ESCALATION FY14 | 15,624 | CHUDAKOV | 1 | 1 | D |  | EUGENE C |  | 11-026 |  |  |  |  |  |  |  |  |  |  |  |  |  | 2553080 | D |  | 13-015 | PR | EJ |  |  |  |  |
| 2553085 |  | Support Control Active Collimator (HallD) FY13 | 20d | 2013-09-03 | 2013-09-30 | 9-130M FS+228d | 20d | 0d | 8/5 M-F w/JLAB Holidays ReBaseline | SCIENTIST [7.73 h]; MECH ENG [3.86 h] | 842.51 | CHUDAKOV | 1 | 1 | D |  | EUGENE C |  | 11-026 |  |  |  |  |  |  |  |  |  |  |  |  |  | 2553085 | S | EJ | 13-015 | PR |  |  |  |  |  |
| 2553090 |  | Proc Hardware for Active Collimator Control (Accelerator Grp) | 183d | 2013-09-03 | 2014-06-02 | 9-130M FS+228d | 44d | 24d | 8/5 M-F w/JLAB Holidays ReBaseline | PROCUREMENT<$50K 60 NO ESCALATION FY14 | 18,800 | CHUDAKOV | 1 | 1 | D |  | EUGENE C |  | 11-026 |  |  |  |  |  |  |  |  |  |  |  |  |  | 2553090 | D |  | 13-015 | PR | EJ |  |  |  |  |
| 2553095 |  | Design Install Feedback System for Active Collimator (Accelerator Grp) FY13 | 20d | 2013-09-03 | 2013-09-30 | 9-130M FS+228d, 2553064 FS-187d | 44d | 0d | 8/5 M-F w/JLAB Holidays ReBaseline | ELEC TECH [69.95 h]; ELEC ENG [19.67 h] | 4,617.77 | CHUDAKOV | 1 | 1 | D |  | EUGENE C |  | 11-026 |  |  |  |  |  |  |  |  |  |  |  |  |  | 2553095 | S | EJ | 13-015 | PR |  |  |  |  |  |
| 2553110 |  | Manufacturing Drawings for Goniometer vacuum chamber | 20d | 2013-09-03 | 2013-09-30 | 9-130M FS+228d | 95d | 24d | 8/5 M-F w/JLAB Holidays ReBaseline | MECH ENG [11.2 h]; MECH DES [16.8 h] | 1,645.56 | CHUDAKOV | 1 | 1 | D |  | EUGENE C |  |  |  |  |  |  |  |  |  |  |  |  |  |  |  | 2553110 | S | PE | 13-015 | PR |  |  | 13-007 |  |  |
| 2553140 |  | Manufacturing Drawings of Amorphous target insertion device (E-beam) FY13 | 20d | 2013-09-03 | 2013-09-30 | 9-130M FS+228d | 117d | 0d | 8/5 M-F w/JLAB Holidays ReBaseline | MECH ENG [7.55 h]; MECH DES [22.64 h] | 1,671.7 | CHUDAKOV | 1 | 1 | D |  | EUGENE C |  |  |  |  |  |  |  |  |  |  |  |  |  |  |  | 2553140 | S | PE | 13-015 | PR |  |  | 13-007 |  |  |
| 2553145 |  | Fab Amorphous insertion device (e-beam) (Previously Obligated) | 70d | 2013-09-03 | 2013-12-11 | 2553140a FS-53d, 2553140 FS-53d | 117d | 99d | 8/5 M-F w/JLAB Holidays ReBaseline | PROCUREMENT<$50K 60 NO ESCALATION FY14 | 15,066 | CHUDAKOV | 1 | 1 | D |  | EUGENE C |  |  |  |  |  |  |  |  |  |  |  |  |  |  |  | 2553145 | D |  | 13-015 | PR | PE | y | 13-007 | OB |  |
| 2553147 |  | Fab Amorphous insertion device (e-beam) | 70d | 2013-09-03 | 2013-12-11 | 2553140a FS-53d, 2553140 FS-53d | 117d | 99d | 8/5 M-F w/JLAB Holidays ReBaseline | PROCUREMENT<$50K 60 NO ESCALATION FY14 | 4,344 | CHUDAKOV | 1 | 1 | D |  | EUGENE C |  |  |  |  |  |  |  |  |  |  |  |  |  |  |  | 2553145 | D |  | 13-015 | PR | PE |  | 13-007 |  |  |
| 2553170 |  | Procure goniometer vacuum pump/instrumentation | 73d | 2013-09-03 | 2013-12-16 | 9-130M FS+228d | 154d | 136d | 8/5 M-F w/JLAB Holidays ReBaseline | PROCUREMENT<$50K 60 NO ESCALATION FY14 | 5,238 | CHUDAKOV | 1 | 1 | D |  | EUGENE C |  |  |  |  |  |  |  |  |  |  |  |  |  |  |  | 2553170 | D |  | 13-015 | PR | CP |  | 13-007 |  |  |
| 2553175 |  | Fab Tagger beamline components | 20d | 2013-09-03 | 2013-09-30 | 9-130M FS+228d | 263d | 55d | 8/5 M-F w/JLAB Holidays ReBaseline | MECH TECH [36 h] | 1,650.96 | CHUDAKOV | 1 | 1 | D |  | EUGENE C |  |  |  |  |  |  |  |  |  |  |  |  |  |  |  | 2553175 | S | PE | 13-015 | PR |  |  | 13-007 |  |  |
| 2553057 |  | Sientific support for Pair spectrometer characterization(BL Compnts) FY13 | 1d | 2013-09-30 | 2013-09-30 | 2553050 FS-32d, 2553052 FS-32d | 191d | 0d | 8/5 M-F w/JLAB Holidays ReBaseline | SCIENTIST [2.06 h] | 150.09 | CHUDAKOV | 1 | 1 | D |  | EUGENE C | 11-006 | 11-026 |  |  |  |  | 12-021 |  | 12-054 |  |  |  |  |  |  | 2553057 | S | PE | 13-015 | PR |  |  | 13-007 |  |  |
| 2553005 |  | Proc Raw Radiator Diamond Crystals (BL Compnts) | 219d | 2013-10-01 | 2014-08-20 | 9-140M | 377d | 0d | 8/5 M-F w/JLAB Holidays ReBaseline | PROCUREMENT<$50K 60 | 38,634.34 | CHUDAKOV | 1 | 1 | D |  | EUGENE C | 11-006 | 11-026 |  |  |  |  | 12-021 |  | 12-054 |  |  |  |  |  |  | 2553005 | D |  | 13-015 | PR | EV |  |  |  | 14-001 |
| 2553011a |  | Diamond contractor and procurements support (BL Compnts) FY14 | 247d | 2013-10-01 | 2014-09-30 | 2553011, 9-130M FS+228d | 0d |  | 8/5 M-F w/JLAB Holidays ReBaseline | SCIENTIST [88.81 h]; MECH ENG [29.6 h] | 8,886.97 | CHUDAKOV | 1 | 1 | D |  | EUGENE C | 11-006 | 11-026 |  |  |  |  | 12-021 |  | 12-054 |  |  |  |  |  |  | 2553011 | E | PE | 13-015 | PR |  |  |  |  | 14-001 |
| 2553057a |  | Sientific support for Pair spectrometer characterization(BL Compnts) FY14 | 154d | 2013-10-01 | 2014-05-19 | 2553050 FS-32d, 2553052 FS-32d, 2553057 | 191d | 1d | 8/5 M-F w/JLAB Holidays ReBaseline | SCIENTIST [317.94 h] | 23,902.73 | CHUDAKOV | 1 | 1 | D |  | EUGENE C | 11-006 | 11-026 |  |  |  |  | 12-021 |  | 12-054 |  |  |  |  |  |  | 2553057 | S | PE | 13-015 | PR |  |  | 13-007 |  | 14-001 |
| 2553072b |  | Program & test Collimator Table (BL Components) FY14 | 51d | 2013-10-01 | 2013-12-12 | 9-130M FS+228d, 2553072a | 156d | 136d | 8/5 M-F w/JLAB Holidays ReBaseline | SCIENTIST [57.47 h]; ELEC ENG [28.73 h] | 6,479.08 | CHUDAKOV | 1 | 1 | D |  | EUGENE C | 11-006 | 11-026 |  | 09-014 |  |  |  |  |  |  |  |  | 12-053 |  |  | 2553072a | S | EJ | 13-015 | PR |  |  |  |  | 14-001 |
| 2553085a |  | Support Control Active Collimator (HallD) FY14 | 187d | 2013-10-01 | 2014-07-07 | 9-130M FS+228d, 2553085 | 20d | 0d | 8/5 M-F w/JLAB Holidays ReBaseline | SCIENTIST [72.27 h]; MECH ENG [36.14 h] | 8,131.83 | CHUDAKOV | 1 | 1 | D |  | EUGENE C |  | 11-026 |  |  |  |  |  |  |  |  |  |  |  |  |  | 2553085 | S | EJ | 13-015 | PR |  |  |  |  | 14-001 |
| 2553095a |  | Design Install Feedback System for Active Collimator (Accelerator Grp) FY14 | 163d | 2013-10-01 | 2014-06-02 | 9-130M FS+228d, 2553095, 2553064 FS-187d | 44d | 24d | 8/5 M-F w/JLAB Holidays ReBaseline | ELEC TECH [570.05 h]; ELEC ENG [160.33 h] | 38,832.17 | CHUDAKOV | 1 | 1 | D |  | EUGENE C |  | 11-026 |  |  |  |  |  |  |  |  |  |  |  |  |  | 2553095 | S | EJ | 13-015 | PR |  |  |  |  | 14-001 |

| ID | Activity | Duration | Start | Finish | Predecessors | Total float | Free float | Calendar | Resources | Cost | Original Activity ID Rebaseline | RESP - Responsibility | STRT%COMP for CM EVM | FNSH%COMP for CM EVM | HALL D Related Milestones | EVMS Reporting Codes | CAM RESPONSIBLE | CR 13-007 | BOE Labor | CR 13-015 | Post Rebaseline | CR 14-001 | CR 11-026 | CR 12-021 | CR 12-055 | BOE Procurement | BOE Expenses | CR 08-016 | CR 09-012 | CR 09-027 | CR 09-027 Repair | CR 11-004 | CR 11-006 | CR 12-054 |
| --- | --- | --- | --- | --- | --- | --- | --- | --- | --- | --- | --- | --- | --- | --- | --- | --- | --- | --- | --- | --- | --- | --- | --- | --- | --- | --- | --- | --- | --- | --- | --- | --- | --- | --- |
| 2553140a | Manufacturing Drawings of Amorphous target insertion device (E-beam) FY14 | 33d | 2013-10-01 | 2013-11-14 | 2553140, 9-130M FS+228d | 117d | 0d | 8/5 M-F w/JLAB Holidays ReBaseline | MECH ENG [12.45 h]; MECH DES [37.36 h] | 2,846.27 | 2553140 | CHUDAKOV | 1 | 1 | D | S | EUGENE C | 13-007 | PE | 13-015 | PR | 14-001 |  |  |  |  |  |  |  |  |  |  |  |  |
| 2553044 | Build PS High granularity Support Frame | 55d | 2013-10-03 | 2013-12-20 | 9-140M FS+2d | 155d | 18d | 8/5 M-F w/JLAB Holidays ReBaseline | PROCUREMENT<$50K 60 | 5,758 | 2553044 | CHUDAKOV | 1 | 1 | D | D | EUGENE C | 13-007F |  | 13-015 | PR | 14-001 | 11-026 | 12-021 | 12-055 | PE |  |  |  |  |  |  |  |  |
| 2553130 | Manufacturing Drawings of cooling system for PS detector | 48d | 2013-10-04 | 2013-12-12 | 9-140M FS+3d | 137d | 0d | 8/5 M-F w/JLAB Holidays ReBaseline | MECH ENG [112.8 h]; MECH DES [206.8 h] | 19,031.62 | 2553130 | CHUDAKOV | 1 | 1 | D | S | EUGENE C | 13-007 | PE | 13-015 | PR | 14-001 |  |  |  |  |  |  |  |  |  |  |  |  |
| 2553125 | Install mounting frame for low granularity PS detectors | 43d | 2013-10-21 | 2013-12-20 | 2553041 FS+13d | 155d | 18d | 8/5 M-F w/JLAB Holidays ReBaseline | MECH TECH [139.2 h]; SUPPLIES & MATERIALS; MECH ENG [3.48 h]; MECH DES [3.48 h] | 7,115.09 | 2553125 | CHUDAKOV | 1 | 1 | D | S | EUGENE C | 13-007 | PE | 13-015 | PR | 14-001 |  |  |  |  | EJ |  |  |  |  |  |  |  |
| 2553016 | Build Vacuum Housing for Goniometer (BL Compnts) | 58d | 2013-11-04 | 2014-02-06 | 9-140M FS+24d, 2553110 | 71d | 53d | 8/5 M-F w/JLAB Holidays ReBaseline | PROCUREMENT<$50K 60 | 24,916.85 | 2553016 | CHUDAKOV | 1 | 1 | D | D | EUGENE C | 13-007 |  | 13-015 | PR | 14-001 | 11-026 | 12-021 |  | PE |  | 08-016 | 09-012 | 09-027 | 09-027 | 11-004 | 11-006 | 12-054 |
| 2553055 | Assemble and Test Pair convertor (BL Compnts) | 70d | 2013-11-26 | 2014-03-18 | 2553052 FS+9d, 2553050 FS+9d | 108d | 0d | 8/5 M-F w/JLAB Holidays ReBaseline | MECH TECH [160 h]; MECH ENG [80 h]; MECH DES [160 h]; SCIENTIST [40 h] | 24,760 | 2553055 | CHUDAKOV | 1 | 1 | D | S | EUGENE C | 13-007 | PE | 13-015 | PR | 14-001 | 11-026 | 12-021 |  |  |  |  |  |  |  |  | 11-006 | 12-054 |
| 2553185 | Manufacturing Drawings of Photon beamline to dump | 21d | 2013-11-26 | 2014-01-07 | 9-140M FS+40d | 133d | 0d | 8/5 M-F w/JLAB Holidays ReBaseline | MECH ENG [120 h]; MECH DES [160 h] | 17,168.4 | 2553185 | CHUDAKOV | 1 | 1 | D | S | EUGENE C | 13-007 | PE | 13-015 | PR | 14-001 |  |  |  |  |  |  |  |  |  |  |  |  |
| 2553020 | Write Control Software for Goniometer (BL Compnts) | 125d | 2013-12-02 | 2014-06-06 | 9-140M FS+42d | 27d | 9d | 8/5 M-F w/JLAB Holidays ReBaseline | SCIENTIST [320 h] | 24,057.6 | 2553020 | CHUDAKOV | 1 | 1 | D | S | EUGENE C |  | EJ | 13-015 | PR | 14-001 | 11-026 | 12-021 |  |  |  |  |  |  |  | 11-004 | 11-006 | 12-054 |
| 2553190 | Fabricate photon beamline to dump | 29d | 2013-12-02 | 2014-01-22 | 2553185 FS-19d | 133d | 0d | 8/5 M-F w/JLAB Holidays ReBaseline | PROCUREMENT<$50K 60 | 12,589.18 | 2553190 | CHUDAKOV | 1 | 1 | D | D | EUGENE C | 13-007 |  | 13-015 | PR | 14-001 |  |  |  | EJ |  |  |  |  |  |  |  |  |
| 2553010 | Thinning-Characterization-Mounting of Radiator Diamond Crystals (BL Compnts) Phase 1 | 202d | 2013-12-05 | 2014-09-30 | 2553005 FS-174d | 377d | 0d | 8/5 M-F w/JLAB Holidays ReBaseline | PROCUREMENT<$50K 60; PROCUREMENT>$50K 69 | 55,206.65 | 2553010 | CHUDAKOV | 1 | 1 | D | D | EUGENE C |  |  | 13-015 | PR | 14-001 | 11-026 | 12-021 |  | EV |  |  |  |  |  |  | 11-006 | 12-054 |
| 2553160 | Manufacturing Drawings of radiator holder | 34d | 2013-12-05 | 2014-02-03 | 9-140M FS+45d | 18d | 0d | 8/5 M-F w/JLAB Holidays ReBaseline | MECH ENG [80 h]; MECH DES [160 h] | 14,181.6 | 2553160 | CHUDAKOV | 1 | 1 | D | S | EUGENE C | 13-007 | EJ | 13-015 | PR | 14-001 |  |  |  |  |  |  |  |  |  |  |  |  |
| 2553135 | Procure cooling system for PS detector | 44d | 2013-12-12 | 2014-02-24 | 2553130 FS-1d | 137d | 0d | 8/5 M-F w/JLAB Holidays ReBaseline | PROCUREMENT<$50K 60 | 5,778.64 | 2553135 | CHUDAKOV | 1 | 1 | D | D | EUGENE C | 13-007 |  | 13-015 | PR | 14-001 |  |  |  | EJ |  |  |  |  |  |  |  |  |
| 2553150 | Manufacturing Drawings of polarimeter vacuum chamber | 49d | 2013-12-16 | 2014-03-05 | 9-140M FS+52d | 81d | 0d | 8/5 M-F w/JLAB Holidays ReBaseline | MECH ENG [120 h]; MECH DES [240 h] | 21,272.4 | 2553150 | CHUDAKOV | 1 | 1 | D | S | EUGENE C | 13-007 | PE | 13-015 | PR | 14-001 |  |  |  |  |  |  |  |  |  |  |  |  |
| 2553195 | Install photon beamline to dump | 39d | 2014-01-29 | 2014-03-24 | 2553190 FS+4d | 133d | 115d | 8/5 M-F w/JLAB Holidays ReBaseline | MECH TECH [200 h]; SUPPLIES & MATERIALS; MECH ENG [4 h]; MECH DES [4 h] | 10,071.07 | 2553195 | CHUDAKOV | 1 | 1 | D | S | EUGENE C | 13-007 | PE | 13-015 | PR | 14-001 |  |  |  |  | EJ |  |  |  |  |  |  |  |
| 2553165 | Fab radiator holder | 31d | 2014-02-05 | 2014-03-19 | 2553160 FS+1d, 9-140M FS+70d | 18d | 0d | 8/5 M-F w/JLAB Holidays ReBaseline | PROCUREMENT<$50K 60 | 3,714.84 | 2553165 | CHUDAKOV | 1 | 1 | D | D | EUGENE C | 13-007 |  | 13-015 | PR | 14-001 |  |  |  | PE |  |  |  |  |  |  |  |  |
| 2553200 | Manufacturing Drawings of Total Absorption Counter | 24d | 2014-02-05 | 2014-03-10 | 9-140M FS+80d | 35d | 0d | 8/5 M-F w/JLAB Holidays ReBaseline | MECH ENG [120 h]; MECH DES [200 h] | 19,220.4 | 2553200 | CHUDAKOV | 1 | 1 | D | S | EUGENE C | 13-007 | PE | 13-015 | PR | 14-001 |  |  |  |  |  |  |  |  |  |  |  |  |
| 2553155 | Fab polarimeter vacuum chamber | 5d | 2014-03-18 | 2014-03-24 | 2553150 FS+8d | 81d | 0d | 8/5 M-F w/JLAB Holidays ReBaseline | PROCUREMENT<$50K 60 | 6,088.21 | 2553155 | CHUDAKOV | 1 | 1 | D | D | EUGENE C | 13-007 |  | 13-015 | PR | 14-001 |  |  |  | EJ |  |  |  |  |  |  |  |  |
| 2553157 | Install polarimeter | 52d | 2014-03-25 | 2014-06-05 | 2553155 | 81d |  | 8/5 M-F w/JLAB Holidays ReBaseline | MECH ENG [20 h]; MECH TECH [80 h]; SCIENTIST [20 h]; SUPPLIES & MATERIALS | 6,988.98 | 2553157 | CHUDAKOV | 1 | 1 | D | S | EUGENE C | 13-007 | EJ | 13-015 | PR | 14-001 |  |  |  |  | EJ |  |  |  |  |  |  |  |
| 2553205 | Fabricate Total Absorption Counter Support | 64d | 2014-04-02 | 2014-07-01 | 2553200 FS+16d | 35d | 0d | 8/5 M-F w/JLAB Holidays ReBaseline | PROCUREMENT<$50K 60 | 6,500.97 | 2553205 | CHUDAKOV | 1 | 1 | D | S | EUGENE C | 13-007 |  | 13-015 | PR | 14-001 |  |  |  | EJ |  |  |  |  |  |  |  |  |
| 2553027 | Install Goniometer (BL Compnts) | 41d | 2014-04-23 | 2014-06-19 | 2553016, 282453000 FS-94d, 2553020 FS-41d, 2553016 FF | 18d | 0d | 8/5 M-F w/JLAB Holidays ReBaseline | SCIENTIST [320 h]; MECH TECH [160 h]; MECH ENG [40 h]; MECH DES [80 h] | 38,719.6 | 2553027 | CHUDAKOV | 1 | 1 | D | S | EUGENE C | 13-007 | EJ | 13-015 | PR | 14-001 | 11-026 | 12-021 |  |  |  |  |  |  |  | 11-004 | 11-006 | 12-054 |
| 2553029 | Survey Goniometer (BL Compnts) | 53d | 2014-06-20 | 2014-09-04 | 2553027 | 18d |  | 8/5 M-F w/JLAB Holidays ReBaseline | SCIENTIST [240 h]; MECH TECH [80 h]; MECH ENG [120 h] | 30,789.2 | 2553029 | CHUDAKOV | 1 | 1 | D | S | EUGENE C | 13-007 | PE | 13-015 | PR | 14-001 | 11-026 | 12-021 |  |  |  |  |  |  |  | 11-004 | 11-006 | 12-054 |
| 2553210 | Install Total Absorption Counter | 28d | 2014-07-02 | 2014-08-11 | 2553205 | 35d |  | 8/5 M-F w/JLAB Holidays ReBaseline | MECH TECH [120 h]; SUPPLIES & MATERIALS; MECH ENG [60 h]; COMP SCIENT; MECH DES [8 h] | 10,672.19 | 2553210 | CHUDAKOV | 1 | 1 | D | S | EUGENE C | 13-007 | EJ | 13-015 | PR | 14-001 |  |  |  |  | EJ |  |  |  |  |  |  |  |
| 2553075 | Test Active Collimator (BL Compnts) | 40d | 2014-07-08 | 2014-09-02 | 2553095a, 2553085a, 2553064, 2553085, 2553072a, 2553080, 2553072b, 2553062 FS+22d, 2553090, 2553095 | 20d |  | 8/5 M-F w/JLAB Holidays ReBaseline | SCIENTIST [40 h]; PD UNIV STUDNT [320 h]; CONTRB UNIV LBR [320 h] | 6,642.4 | 2553075 | CHUDAKOV | 1 | 1 | D | S | EUGENE C |  | EJ | 13-015 | PR | 14-001 | 11-026 |  |  |  |  |  |  |  |  |  |  |  |
| 2553010a | Thinning-Characterization-Mounting of Radiator Diamond Crystals (BL Compnts) | 120d | 2014-10-01 | 2015-04-01 | 2553010 | 377d | 0d | 8/5 M-F w/JLAB Holidays ReBaseline | PROCUREMENT<$50K 60 | 30,957 | 2553010a | CHUDAKOV | 1 | 1 | D | D | EUGENE C |  |  | 13-015 | PR | 14-001 | 11-026 | 12-021 |  | EV |  |  |  |  |  |  | 11-006 | 12-054 |

| ID | WBS | Activity | Type | Duration | Start | Finish | Predecessors | Total float | Free float | Calendar | Resources | Cost | RESP - Responsibility | STRT%COMP for CM EVM | FNSH%COMP for CM EVM | HALL D Related Milestones | CR 07-024 | CAM RESPONSIBLE | CR 09-043 | CR 11-006 | CR 11-026 | CR 12-021 | CR 12-054 | CR 11-001 | 12 GeV 1st level Critical Path | CR 09-014 | CR 09-027 | CR 09-027 Repair | CR 11-054 | CR 12-053 | Milestone Level | CR 10-042 | CR 09-012 | CR 13-014 | ReBaseline Actuals Adjustment | Original Activity ID Rebaseline | EVMS Reporting Codes | CR 13-007 | BOE Labor | BOE Expenses | CR 13-015 | Post Rebaseline | CR 14-001 | BOE Procurement | CR 12-049 |
| --- | --- | --- | --- | --- | --- | --- | --- | --- | --- | --- | --- | --- | --- | --- | --- | --- | --- | --- | --- | --- | --- | --- | --- | --- | --- | --- | --- | --- | --- | --- | --- | --- | --- | --- | --- | --- | --- | --- | --- | --- | --- | --- | --- | --- | --- |
|  | 6 | **1.5.6 INFRASTRUCTURE** |  |  | 2009-06-01 | 2014-10-01 |  |  |  |  |  |  |  |  |  |  |  |  |  |  |  |  |  |  |  |  |  |  |  |  |  |  |  |  |  |  |  |  |  |  |  |  |  |  |  |
|  | 1 | **1.5.6.1 ASSEMBLY** |  |  | 2010-02-11 | 2014-04-25 |  |  |  |  |  |  |  |  |  |  |  |  |  |  |  |  |  |  |  |  |  |  |  |  |  |  |  |  |  |  |  |  |  |  |  |  |  |  |  |
| 1561065 |  | Receive Modules 1-4 (Assy) |  | 5d | 2010-02-11 | 2010-02-18 | 15221215, 15221235, 15221205, 15221225 | 646d | 624d |  | PROCUREMENT<$50K 60; MECH ENG [5.33 h]; PLABOR; MECH TECH [26.67 h] | 6,079.18 | CHUDAKOV | 1 | 1 | D | 07-024 | EUGENE C | 09-043 | 11-006 | 11-026 | 12-021F | 12-054F |  |  |  |  |  |  |  |  |  |  |  |  |  |  |  |  |  |  |  |  |  |  |
| 1561070 |  | Receive Modules 5-8 (Assy) |  | 5d | 2010-04-28 | 2010-05-04 | 15221265, 15221275, 15221245, 15221255 | 593d | 571d |  | PROCUREMENT<$50K 60; MECH ENG [5.33 h]; MECH TECH [26.67 h]; PLABOR | 6,079.18 | CHUDAKOV | 1 | 1 | D | 07-024 | EUGENE C | 09-043 | 11-006 | 11-026 | 12-021F | 12-054F |  |  |  |  |  |  |  |  |  |  |  |  |  |  |  |  |  |  |  |  |  |  |
| 1561075 |  | Receive Modules 9-12 (Assy) |  | 5d | 2010-07-13 | 2010-07-19 | 195221065, 195221035, 195221055, 195221045 | 541d | 519d |  | MECH TECH [26.67 h]; PROCUREMENT<$50K 60; MECH ENG [5.33 h]; PLABOR | 6,079.18 | CHUDAKOV | 1 | 1 | D | 07-024 | EUGENE C | 09-043 | 11-006 | 11-026 | 12-021F | 12-054F |  |  |  |  |  |  |  |  |  |  |  |  |  |  |  |  |  |  |  |  |  |  |
| 1561080 |  | Receive Modules 13-16 (Assy) FY10 |  | 4d | 2010-09-27 | 2010-09-30 | 195221085, 195221105, 195221075, 195221095 | 488d | 0d |  | MECH TECH [21.34 h]; MECH ENG [4.26 h]; PLABOR | 2,929.31 | CHUDAKOV | 1 | 1 | D | 07-024 | EUGENE C | 09-043 | 11-006 | 11-026 | 12-021F | 12-054F | 11-001 |  |  |  |  |  |  |  |  |  |  |  |  |  |  |  |  |  |  |  |  |  |
| 1561080b |  | Receive Modules 13-16 (Assy) Procurement |  | 5d | 2010-09-27 | 2010-10-01 | 195221085, 195221105, 195221075, 195221095 | 488d | 466d |  | PROCUREMENT<$50K 60 NO ESCALATION FY11 | 2,417.33 | CHUDAKOV | 1 | 1 | D | 07-024 | EUGENE C | 09-043 | 11-006 | 11-026 | 12-021F | 12-054F | 11-001 |  |  |  |  |  |  |  |  |  |  |  |  |  |  |  |  |  |  |  |  |  |
| 1561080a |  | Receive Modules 13-16 (Assy) FY11 |  | 1d | 2010-10-01 | 2010-10-01 | 1561080 | 488d | 466d |  | MECH TECH [5.33 h]; MECH ENG [1.07 h]; PLABOR | 755.81 | CHUDAKOV | 1 | 1 | D | 07-024 | EUGENE C | 09-043 | 11-006 | 11-026 | 12-021F | 12-054F | 11-001 |  |  |  |  |  |  |  |  |  |  |  |  |  |  |  |  |  |  |  |  |  |
| 1561085 |  | Receive Modules 17-20 (Assy) |  | 5d | 2010-12-30 | 2011-01-06 | 195221145, 195221125, 195221115, 195221135 | 427d | 405d |  | MECH TECH [26.67 h]; MECH ENG [5.33 h]; PLABOR; PROCUREMENT<$50K 60 | 6,273.05 | CHUDAKOV | 1 | 1 | D | 07-024 | EUGENE C | 09-043 | 11-006 | 11-026 | 12-021F | 12-054F |  |  |  |  |  |  |  |  |  |  |  |  |  |  |  |  |  |  |  |  |  |  |
| 1561090 |  | Receive Modules 21-24 (Assy) |  | 5d | 2011-02-24 | 2011-03-02 | 195221155, 195221175, 195221185, 195221165 | 390d | 368d |  | PLABOR; PROCUREMENT<$50K 60; MECH ENG [5.33 h]; MECH TECH [26.67 h] | 6,273.05 | CHUDAKOV | 1 | 1 | D | 07-024 | EUGENE C | 09-043 | 11-006 | 11-026 | 12-021F | 12-054F |  |  |  |  |  |  |  |  |  |  |  |  |  |  |  |  |  |  |  |  |  |  |
| 1561095 |  | Receive Modules 25-28 (Assy) |  | 5d | 2011-05-11 | 2011-05-17 | 195221215, 195221225, 195221205, 195221195 | 336d | 314d |  | PLABOR; PROCUREMENT<$50K 60; MECH ENG [5.33 h]; MECH TECH [26.67 h] | 6,273.05 | CHUDAKOV | 1 | 1 | D | 07-024 | EUGENE C | 09-043 | 11-006 | 11-026 | 12-021F | 12-054F |  |  |  |  |  |  |  |  |  |  |  |  |  |  |  |  |  |  |  |  |  |  |
| 1561100 |  | Receive Modules 29-32 (Assy) |  | 5d | 2011-07-26 | 2011-08-01 | 195221235, 195221245, 195221255, 195221265 | 284d | 262d |  | MECH TECH [26.67 h]; PLABOR; PROCUREMENT<$50K 60; MECH ENG [5.33 h] | 6,273.05 | CHUDAKOV | 1 | 1 | D | 07-024 | EUGENE C | 09-043 | 11-006 | 11-026 | 12-021F | 12-054F |  | 1 |  |  |  |  |  |  |  |  |  |  |  |  |  |  |  |  |  |  |  |  |
| 1561101 |  | Receive Modules 33-36 (Assy) |  | 5d | 2011-10-10 | 2011-10-14 | 195221275, 195221310, 195221300, 195221290 | 231d | 209d |  | MECH TECH [26.67 h]; PLABOR; PROCUREMENT<$50K 60; MECH ENG [5.33 h] | 6,473.07 | CHUDAKOV | 1 | 1 | D | 07-024 | EUGENE C | 09-043 | 11-006 | 11-026 | 12-021F | 12-054F |  | 1 |  |  |  |  |  |  |  |  |  |  |  |  |  |  |  |  |  |  |  |  |
| 1561102 |  | Receive Modules 37-40 (Assy) |  | 5d | 2011-12-29 | 2012-01-05 | 195221340, 195221330, 195221350, 195221320 | 180d | 158d |  | MECH TECH [26.67 h]; PLABOR; PROCUREMENT<$50K 60; MECH ENG [5.33 h] | 6,473.07 | CHUDAKOV | 1 | 1 | D | 07-024 | EUGENE C | 09-043 | 11-006 | 11-026 | 12-021F | 12-054F |  | 1 |  |  |  |  |  |  |  |  |  |  |  |  |  |  |  |  |  |  |  |  |
| 1561103 |  | Receive Modules 41-44 (Assy) |  | 5d | 2012-03-08 | 2012-03-14 | 195221390, 195221380, 195221370, 195221360 | 133d | 111d |  | MECH ENG [5.33 h]; MECH TECH [26.67 h]; PLABOR; PROCUREMENT<$50K 60 | 6,473.07 | CHUDAKOV | 1 | 1 | D | 07-024 | EUGENE C | 09-043 | 11-006 | 11-026 | 12-021F | 12-054F |  | 1 |  |  |  |  |  |  |  |  |  |  |  |  |  |  |  |  |  |  |  |  |
| 1561104 |  | Receive Modules 45-48 (Assy) |  | 5d | 2012-05-23 | 2012-05-30 | 195221400, 195221420, 195221410, 195221430 | 79d | 57d |  | PLABOR; PROCUREMENT<$50K 60; MECH ENG [5.33 h]; MECH TECH [26.67 h] | 6,473.07 | CHUDAKOV | 1 | 1 | D | 07-024 | EUGENE C | 09-043 | 11-006 | 11-026 | 12-021F | 12-054F |  | 1 |  |  |  |  |  |  |  |  |  |  |  |  |  |  |  |  |  |  |  |  |
| 1561155 |  | Assemble BCal readout wedges(Assy) FY12 |  | 40d | 2012-08-03 | 2012-09-28 | 1562242, 1562240b, 15221156n FS-40d, 1561105a FS-85d, 1562240a | 20d | 0d |  | MECH ENG [53.78 h]; MECH TECH [147.9 h] | 10,343.73 | CHUDAKOV | 1 | 1 | D |  | EUGENE C | 09-043 | 11-006 | 11-026 | 12-021 | 12-054F |  |  | 09-014 | 09-027 | 09-027 | 11-054 | 12-053 |  |  |  |  |  |  |  |  |  |  |  |  |  |  |  |
| 1561155b |  | Assemble BCal readout wedges(Assy) Procurement |  | 119d | 2012-08-03 | 2013-01-30 | 1562242, 1562240a, 1562240b, 15221156n FS-40d, 1561105a FS-85d | 130d | 110d |  | PROCUREMENT<$50K 60 NO ESCALATION FY13 | 25,000 | CHUDAKOV | 1 | 1 | D |  | EUGENE C | 09-043 | 11-006 | 11-026 | 12-021 |  |  |  | 09-014 | 09-027 | 09-027 | 11-054 | 12-053 |  |  |  |  |  |  |  |  |  |  |  |  |  |  |  |
| 1561105 |  | BCAL lightguide gluing, preparation for installation (Assy) FY12 |  | 28d | 2012-08-21 | 2012-09-28 | 15221030, 1561080b, 195221435M, 1561103, 1561075, 15221160aba, 15221009, 15221160ab, 15221160b, 1561085, 15221020, 1561102, 1561070, 1561104, 15221165, 1561090, 1561101, 1561095, 1561065, 1561080a, 1561100 | 22d | 0d |  | MECH TECH [478.97 h]; MECH DES [29.47 h]; MECH ENG [29.47 h] | 24,771.44 | CHUDAKOV | 1 | 1 | D | 07-024 | EUGENE C | 09-043 | 11-006 | 11-026 | 12-021 | 12-054F |  | 1 |  |  |  |  | 12-053 |  |  |  |  |  |  |  |  |  |  |  |  |  |  |  |
| 1561105a |  | BCAL lightguide gluing, preparation for installation (Assy) FY13 |  | 43d | 2012-10-01 | 2012-11-30 | 1561105 | 22d | 0d |  | MECH ENG [45.27 h]; MECH TECH [735.55 h]; MECH DES [45.27 h] | 39,258.43 | CHUDAKOV | 1 | 1 | D | 07-024 | EUGENE C | 09-043 | 11-006 | 11-026 | 12-021 | 12-054F |  | 1 |  |  |  |  | 12-053 |  |  |  |  |  |  |  |  |  |  |  |  |  |  |  |
| 1561155a |  | Assemble BCal readout wedges(Assy) FY13 |  | 79d | 2012-10-01 | 2013-01-30 | 1561105a FS-85d, 1562240a, 1561155, 1562242, 15221156n FS-40d, 1562240b | 20d | 0d |  | MECH ENG [106.22 h]; MECH TECH [292.1 h] | 21,081.79 | CHUDAKOV | 1 | 1 | D |  | EUGENE C | 09-043 | 11-006 | 11-026 | 12-021 | 12-054F |  |  | 09-014 | 09-027 | 09-027 | 11-054 | 12-053 |  |  |  |  |  |  |  |  |  |  |  |  |  |  |  |
| 1561050M |  | Complete FDC (Assy) | milestone | 0d | 2013-03-22 | 2013-03-22 | 15211230 | 32d | 12d |  |  |  | CHUDAKOV | 1 | 1 | D |  | EUGENE C |  | 11-006 | 11-026 |  | 12-054 |  |  | 09-014 |  |  |  |  | 6 | 10-042 |  |  |  |  |  |  |  |  |  |  |  |  |  |
| 1561040M |  | Delivery Complete for CDC (Assy) | milestone | 0d | 2013-04-05 | 2013-04-05 | 15212013E, 15212200 | 54d | 0d |  |  |  | CHUDAKOV | 1 | 1 | D |  | EUGENE C |  | 11-006 | 11-026 |  | 12-054F |  |  |  |  |  |  |  | 6 |  |  |  |  |  |  |  |  |  |  |  |  |  |  |
| 1561110 |  | Receive CDC (Assy) |  | 10d | 2013-04-05 | 2013-04-18 | 195212260, 1561040M | 54d | 0d |  | PROCUREMENT<$50K 60; ELEC TECH [400 h]; ELEC ENG [200 h] | 35,434.12 | CHUDAKOV | 1 | 1 | D | 07-024 | EUGENE C |  | 11-006 | 11-026 |  | 12-054F |  |  |  |  |  |  |  |  |  |  |  |  |  |  |  |  |  |  |  |  |  |  |
| 1561140 |  | Receive FDC (Assy) |  | 10d | 2013-04-09 | 2013-04-22 | 15211191 FS-25d, 15211220, 15211012E, 1561050M, 15211185 | 20d | 0d |  | MECH TECH [320 h]; MECH ENG [80 h] | 20,464 | CHUDAKOV | 1 | 1 | D | 07-024 | EUGENE C |  | 11-006 | 11-026 |  | 12-054 |  |  | 09-014 |  |  |  |  |  | 10-042 |  |  |  |  |  |  |  |  |  |  |  |  |  |
| 1561115 |  | Mounting CDC (Assy) |  | 20d | 2013-04-19 | 2013-05-16 | 1561110 | 54d | 0d |  | MECH TECH [160 h]; PROCUREMENT<$50K 60; MECH ENG [80 h] | 43,309.62 | CHUDAKOV | 1 | 1 | D | 07-024 | EUGENE C |  | 11-006 | 11-026 |  | 12-054F |  |  |  |  |  |  |  |  |  | 09-012 |  |  |  |  |  |  |  |  |  |  |  |  |
| 1561145 |  | Rail Mounting for FDC (Assy) |  | 10d | 2013-04-23 | 2013-05-06 | 1561140 | 20d | 0d |  | PROCUREMENT<$50K 60; MECH ENG [283.2 h]; ELEC TECH [144 h] | 59,660.15 | CHUDAKOV | 1 | 1 | D | 07-024 | EUGENE C |  | 11-006 | 11-026 |  | 12-054 |  |  | 09-014 |  |  |  |  |  | 10-042 |  |  |  |  |  |  |  |  |  |  |  |  |  |
| 1561120 |  | Alignment CDC (Assy) |  | 20d | 2013-05-17 | 2013-06-14 | 12361005, 1561115 | 54d | 0d |  | MECH TECH [400 h]; MECH ENG [160 h] | 29,921.6 | CHUDAKOV | 1 | 1 | D | 07-024 | EUGENE C |  | 11-006 | 11-026 |  | 12-054F |  |  |  |  |  |  |  |  |  |  |  |  |  |  |  |  |  |  |  |  |  |  |
| 1561125 |  | Operational Checks CDC (outside Solenoid) (Assy) |  | 20d | 2013-06-17 | 2013-07-15 | 1561120 | 54d | 0d |  | ELEC ENG [200 h]; ELEC TECH [600 h] | 41,886 | CHUDAKOV | 1 | 1 | D | 07-024 | EUGENE C |  | 11-006 | 11-026 |  | 12-054F |  |  |  |  |  |  |  |  |  |  |  |  |  |  |  |  |  |  |  |  |  |  |
| 1561170 |  | Re-Baseline Actuals Adjustment |  | 1d | 2013-08-30 | 2013-08-30 | 9-130M FS+227d | 20d |  |  | PROCUREMENT>$50K 69 NO ESCALATION | -199,966.79 | CHUDAKOV | 1 | 1 |  |  | EUGENE C |  |  |  |  |  |  |  |  |  |  |  |  |  |  |  | 13-014 | ADJ |  |  |  |  |  |  |  |  |  |  |
| 2561145 |  | Rail Mounting for FDC (Assy) FY13 |  | 18d | 2013-09-05 | 2013-09-30 | 2562225 FS-18d | 0d |  | 8/5 M-F w/JLAB Holidays ReBaseline | MECH ENG [6.75 h]; ELEC TECH; MECH DES [4.5 h]; MECH TECH [105.75 h]; SUPPLIES & MATERIALS | 5,899.33 | CHUDAKOV | 1 | 1 | D | 07-024 | EUGENE C |  | 11-006 | 11-026 |  | 12-054 |  |  | 09-014 |  |  |  |  |  | 10-042 |  |  |  | 2561145 | S | 13-007 | PE | EJ | 13-015 | PR |  |  |  |
| 2561050M |  | Complete FDC (Assy) | milestone | 0d | 2013-10-01 | 2013-10-01 | 25211208 | 1d |  | 8/5 M-F w/JLAB Holidays ReBaseline |  |  | CHUDAKOV | 1 | 1 | D |  | EUGENE C |  | 11-006 | 11-026 |  | 12-054 |  |  | 09-014 |  |  |  |  | 6 | 10-042 |  |  |  | 2561050M | M | 13-007 |  |  | 13-015 | PR |  |  |  |
| 2561145a |  | Rail Mounting for FDC (Assy) FY14 |  | 14d | 2013-10-01 | 2013-10-18 | 2561145, 2562225 FS-18d | 0d |  | 8/5 M-F w/JLAB Holidays ReBaseline | MECH ENG [5.25 h]; ELEC TECH; MECH DES [3.5 h]; MECH TECH [82.25 h]; SUPPLIES & MATERIALS | 4,734.51 | CHUDAKOV | 1 | 1 | D | 07-024 | EUGENE C |  | 11-006 | 11-026 |  | 12-054 |  |  | 09-014 |  |  |  |  |  | 10-042 |  |  |  | 2561145 | S | 13-007 | PE | EJ | 13-015 | PR | 14-001 |  |  |
| 2561140 |  | Receive FDC (Assy) |  | 5d | 2013-10-02 | 2013-10-08 | 25211172 FS-9d, 2561050M, 25211220 FS-55d, 25211172a FS-9d | 0d |  | 8/5 M-F w/JLAB Holidays ReBaseline | MECH TECH [40 h]; MECH ENG [20 h] | 3,386.2 | CHUDAKOV | 1 | 1 | D | 07-024 | EUGENE C |  | 11-006 | 11-026 |  | 12-054 |  |  | 09-014 |  |  |  |  |  | 10-042 |  |  |  | 2561140 | S | 13-007 | PE |  | 13-015 | PR | 14-001 |  |  |
| 2561110 |  | Receive CDC for Storage (Assy) |  | 25d | 2013-10-24 | 2013-11-27 | 2561040M FS-6d, 295212260 FS-6d | 63d | 0d | 8/5 M-F w/JLAB Holidays ReBaseline | MECH TECH [80 h]; SCIENTIST [40 h]; MECH ENG [40 h]; ELEC TECH [40 h]; PROCUREMENT<$50K 60 | 14,400.05 | CHUDAKOV | 1 | 1 | D | 07-024 | EUGENE C |  | 11-006 | 11-026 |  | 12-054F |  |  |  |  |  |  |  |  |  |  |  |  | 2561110 | S | 13-007 | EJ |  | 13-015 | PR | 14-001 | EJ |  |
| 2561040M |  | Delivery Complete for CDC (Assy) | milestone | 0d | 2013-11-01 | 2013-11-01 | 295212260 | 63d | 0d | 8/5 M-F w/JLAB Holidays ReBaseline |  |  | CHUDAKOV | 1 | 1 | D |  | EUGENE C |  | 11-006 | 11-026 |  | 12-054F |  |  |  |  |  |  |  | 6 |  |  |  |  | 2561040M | M | 13-007 |  |  | 13-015 | PR |  |  |  |
| 2561060M |  | Delivery Complete for TOF (Assy) | milestone | 0d | 2013-12-02 | 2013-12-02 | 25231010 FS-200d, 25231090, 25231010a FS-200d, 25231145 FS-15d, 25231085 | 69d | 0d | 8/5 M-F w/JLAB Holidays ReBaseline |  |  | CHUDAKOV | 1 | 1 | D |  | EUGENE C |  | 11-006 | 11-026 | 12-021 | 12-054 |  |  |  |  |  |  |  | 6 |  |  |  |  | 2561060M | M | 13-007F |  |  | 13-015 | PR |  |  | 12-049 |
| 2561160 |  | Receive TOF Detector Units (Assy) |  | 10d | 2013-12-02 | 2013-12-13 | 2561060M | 69d | 6d | 8/5 M-F w/JLAB Holidays ReBaseline | MECH TECH [40 h]; MECH ENG [20 h] | 3,386.2 | CHUDAKOV | 1 | 1 | D | 07-024 | EUGENE C |  | 11-006 | 11-026 | 12-021 | 12-054 |  |  |  |  |  |  |  |  |  |  |  |  | 2561160 | S | 13-007F | PE |  | 13-015 | PR | 14-001 |  | 12-049 |
| 2561165 |  | Mount TOF Counters onto Detector Frame (Assy) |  | 60d | 2014-02-03 | 2014-04-25 | 25231030, 25231045, 2561160 FS+20d | 64d | 0d | 8/5 M-F w/JLAB Holidays ReBaseline | MECH TECH [400 h]; PROCUREMENT<$50K 60; MECH ENG [40 h] | 33,127.38 | CHUDAKOV | 1 | 1 | D | 07-024 | EUGENE C |  | 11-006 | 11-026 | 12-021 | 12-054 |  |  |  |  |  |  |  |  |  |  |  |  | 2561165 | S | 13-007F | EJ |  | 13-015 | PR | 14-001 | PE | 12-049 |

| ID | WBS | Activity | Type | Duration | Start | Finish | Predecessors | Total float | Free float | Resources | Cost | RESP - Responsibility | STRT%COMP for CM EVM | FNSH%COMP for CM EVM | HALL D Related Milestones | CR 07-024 | EVMS Reporting Codes | CAM RESPONSIBLE | CR 09-027 | CR 09-027 Repair | CR 11-026 | CR 10-061 | CR 11-004 | CR 11-006 | CR 11-036 | Advance Purchase Plan > 500K | CR 12-021 | CR 09-014 | CR 09-046 | 12 GeV 1st level Critical Path | CR 10-042 | CR 12-054 | CR 12-055 | 12 GeV 2nd level Critical Path | CR 12-001 | CR 10-059 | CR 07-027 | CR 13-014 | Milestone Level | CR 09-043 | CR 11-030 | CR 11-044 |
| --- | --- | --- | --- | --- | --- | --- | --- | --- | --- | --- | --- | --- | --- | --- | --- | --- | --- | --- | --- | --- | --- | --- | --- | --- | --- | --- | --- | --- | --- | --- | --- | --- | --- | --- | --- | --- | --- | --- | --- | --- | --- | --- |
|  | 2 | **1.5.6.2 INSTALLATION** |  |  | 2009-06-01 | 2014-10-01 |  |  |  |  |  |  |  |  |  |  |  |  |  |  |  |  |  |  |  |  |  |  |  |  |  |  |  |  |  |  |  |  |  |  |  |  |
| 1562001LOE |  | FY09 Work Cordinator (Installtn) |  | 86d | 2009-06-01 | 2009-09-30 | 9-090M FS+162d | 20d | 0d | MECH ENG [320 h] | 20,419.2 | CHUDAKOV | 1 | 1 | D | 07-024 | E | EUGENE C | 09-027 | 09-027 | 11-026 |  |  |  |  |  |  |  |  |  |  |  |  |  |  |  |  |  |  |  |  |  |
| 1562002LOE |  | FY10 Work Cordinator (Installtn) |  | 248d | 2009-10-01 | 2010-09-30 | 1562001LOE | 20d | 0d | MECH ENG [1760 h] | 115,896 | CHUDAKOV | 1 | 1 | D | 07-024 | E | EUGENE C | 09-027 | 09-027 | 11-026 |  |  |  |  |  |  |  |  |  |  |  |  |  |  |  |  |  |  |  |  |  |
| 1562010E |  | FY10 Travel (Installtn) |  | 248d | 2009-10-01 | 2010-09-30 | 9-100M | 20d | 0d | TRAVEL | 1,318.54 | CHUDAKOV | 1 | 1 | D | 07-024 |  | EUGENE C |  |  | 11-026 |  |  |  |  |  |  |  |  |  |  |  |  |  |  |  |  |  |  |  |  |  |
| 1562149 |  | Installation Safety & Planning Platform #5 (Installtn) |  | 50d | 2010-05-17 | 2010-07-27 | 2-10M FS-135d | 340d | 250d | MECH TECH [400 h] | 16,696 | CHUDAKOV | 1 | 1 | D | 07-024 |  | EUGENE C |  |  |  | 10-061 | 11-004 | 11-006 | 11-036 |  |  |  |  |  |  |  |  |  |  |  |  |  |  |  |  |  |
| 1562003LOE |  | FY11 Work Cordinator (Installtn) |  | 248d | 2010-10-01 | 2011-09-30 | 1562002LOE | 20d | 0d | MECH ENG [1760 h] | 119,592 | CHUDAKOV | 1 | 1 | D | 07-024 | E | EUGENE C | 09-027 | 09-027 | 11-026 |  |  |  |  |  |  |  |  |  |  |  |  |  |  |  |  |  |  |  |  |  |
| 1562011E |  | FY11 Travel (Installtn) |  | 248d | 2010-10-01 | 2011-09-30 | 1562010E | 20d | 0d | TRAVEL | 1,360.6 | CHUDAKOV | 1 | 1 | D | 07-024 |  | EUGENE C |  |  | 11-026 |  |  |  |  |  |  |  |  |  |  |  |  |  |  |  |  |  |  |  |  |  |
| 1562099d |  | Prepare procurement packages for col cave vacuum |  | 61d | 2011-01-05 | 2011-04-01 | 9-110M FS+60d | 433d | 0d | MECH ENG [80 h]; MECH DES [320 h] | 20,373.6 | CHUDAKOV | 1 | 1 | D | 07-024 |  | EUGENE C |  |  | 11-026 |  |  | 11-006 |  | APP | 12-021F |  |  |  |  |  |  |  |  |  |  |  |  |  |  |  |
| 1562101 |  | Procure hdwre for collimator cave utilities |  | 103d | 2011-01-05 | 2011-06-01 | 9-110M FS+60d | 558d | 2d | PROCUREMENT>$50K 69 | 20,000 | CHUDAKOV | 1 | 1 | D | 07-024 |  | EUGENE C |  |  | 11-026 |  | 11-004 | 11-006 |  | APP | 12-021F | 09-014 | 09-046 |  |  |  |  |  |  |  |  |  |  |  |  |  |
| 1562105 |  | Fab Collimator Cave Stands (Installtn) |  | 103d | 2011-01-05 | 2011-06-01 | 9-110M FS+60d | 549d | 0d | PROCUREMENT>$50K 69 | 11,338.37 | CHUDAKOV | 1 | 1 | D | 07-024 |  | EUGENE C |  |  | 11-026 |  | 11-004 |  |  | APP | 12-021F | 09-014 | 09-046 |  |  |  |  |  |  |  |  |  |  |  |  |  |
| 1562237 |  | Prepare procurement packages for upstream platform |  | 37d | 2011-01-05 | 2011-02-28 | 9-110M FS+60d | 236d | 64d | MECH ENG [120 h]; MECH DES [320 h] | 23,091.6 | CHUDAKOV | 1 | 1 | D | 07-024 |  | EUGENE C | 09-027 | 09-027 | 11-026 |  | 11-004 | 11-006 |  | APP | 12-021F | 09-014 |  | 1 | 10-042 | 12-054F |  |  |  |  |  |  |  |  |  |  |
| 1562102 |  | Install collimator cave utilities(Installtn) |  | 86d | 2011-01-20 | 2011-05-20 | 1562101 FS-95d, 9-110M FS+70d | 556d | 123d | MECH DES [320 h]; MECH ENG [240 h]; MECH TECH [760 h] | 63,978.8 | CHUDAKOV | 1 | 1 | D | 07-024 |  | EUGENE C |  |  | 11-026 |  | 11-004 | 11-006 |  | APP | 12-021F | 09-014 | 09-046 |  |  |  |  |  |  |  |  |  |  |  |  |  |
| 1562595 |  | Installation work space infrastructure (TW's Doublewide) Part A |  | 167d | 2011-02-04 | 2011-09-30 | 9-110M FS+81d | 743d |  | PROCUREMENT<$50K 60; PROCUREMENT>$50K 69 | 58,000 | CHUDAKOV | 1 | 1 | D |  |  | EUGENE C |  |  | 11-026 |  |  | 11-006 |  |  |  |  |  | 1 |  |  | 12-055 |  |  |  |  |  |  |  |  |  |
| 1562595a |  | Installation work space infrastructure (TW's Doublewide) Part B |  | 167d | 2011-02-04 | 2011-09-30 | 9-110M FS+81d | 743d |  | PROCUREMENT>$50K 69 | 17,000 | CHUDAKOV | 1 | 1 | D |  |  | EUGENE C |  |  | 11-026 |  |  | 11-006 |  |  |  |  |  | 1 |  |  | 12-055 |  |  |  |  |  |  |  |  |  |
| 1562600 |  | Installation Equipment infrastructure |  | 167d | 2011-02-04 | 2011-09-30 | 9-110M FS+81d | 743d |  | PROCUREMENT<$50K 60 | 25,000 | CHUDAKOV | 1 | 1 | D |  |  | EUGENE C |  |  | 11-026 |  |  | 11-006 |  |  |  |  |  | 1 |  |  |  |  |  |  |  |  |  |  |  |  |
| 1562100 |  | Fab Collimator Cave Vac (Installtn) |  | 103d | 2011-02-18 | 2011-07-15 | 1562099d FS-30d, 9-110M FS+60d | 433d | 0d | PROCUREMENT>$50K 69 | 11,338.37 | CHUDAKOV | 1 | 1 | D | 07-024 |  | EUGENE C |  |  | 11-026 |  | 11-004 | 11-006 |  | APP | 12-021F | 09-014 | 09-046 |  |  |  |  |  |  |  |  |  |  |  |  |  |
| 1562132 |  | Install Collimator cave stands (Installtn) |  | 85d | 2011-03-03 | 2011-06-30 | 1562105 FS-64d | 549d | 189d | MECH DES [240 h]; MECH ENG [40 h]; MECH TECH [280 h] | 25,980.8 | CHUDAKOV | 1 | 1 | D | 07-024 |  | EUGENE C |  |  | 11-026 |  | 11-004 | 11-006 |  | APP | 12-021F | 09-014 |  |  |  |  |  |  |  |  |  |  |  |  |  |  |
| 1562423 |  | Prepare solenoid and temporary platform Procurements/Fabrication Packages (Installtn) |  | 107d | 2011-05-02 | 2011-09-30 | 9-110M FS+141d | 172d | 0d | MECH ENG [360 h]; MECH DES [800 h] | 61,806 | CHUDAKOV | 1 | 1 | D | 07-024 |  | EUGENE C | 09-027 | 09-027 | 11-026 |  | 11-004 | 11-006 |  |  | 12-021F | 09-014 |  |  |  | 12-054F |  | 2 |  |  |  |  |  |  |  |  |
| 1562240 |  | Fab Upstream Platform CDC #1 (Installtn) Expenses FY11 |  | 87d | 2011-05-31 | 2011-09-30 | 2-10M, 1562237, 1562425 FS-150d | 172d | 0d | PLABOR | 9,702.66 | CHUDAKOV | 1 | 1 | D | 07-024 |  | EUGENE C | 09-027 | 09-027 | 11-026 |  | 11-004 | 11-006 |  | APP | 12-021F | 09-014 |  | 1 | 10-042 | 12-054F |  |  | 12-001 |  |  |  |  |  |  |  |
| 1562240b |  | Fab Upstream Platform CDC #1 (Installtn) Procurement |  | 122d | 2011-05-31 | 2011-11-18 | 2-10M, 1562425 FS-150d, 1562237 | 172d | 0d | PROCUREMENT>$50K 69 NO ESCALATION FY12 | 73,699.37 | CHUDAKOV | 1 | 1 | D | 07-024 |  | EUGENE C | 09-027 | 09-027 | 11-026 |  | 11-004 | 11-006 |  | APP | 12-021F | 09-014 |  | 1 | 10-042 | 12-054F |  |  | 12-001 |  |  |  |  |  |  |  |
| 1562100b |  | Install col cave vacuum FY11 |  | 54d | 2011-07-18 | 2011-09-30 | 1562100, 1562099d | 433d | 0d | MECH DES [25.41 h]; MECH TECH [304.94 h]; MECH ENG [25.41 h] | 16,046.52 | CHUDAKOV | 1 | 1 | D | 07-024 |  | EUGENE C |  |  | 11-026 |  |  | 11-006 |  | APP | 12-021F |  |  |  |  |  |  |  | 12-001 |  |  |  |  |  |  |  |
| 1562004LOE |  | FY12 Work Cordinator (Installtn) |  | 247d | 2011-10-03 | 2012-09-28 | 1562003LOE | 20d | 0d | MECH ENG [1760 h] | 123,411.2 | CHUDAKOV | 1 | 1 | D | 07-024 | E | EUGENE C | 09-027 | 09-027 | 11-026 |  |  |  |  |  |  |  |  |  |  |  |  |  |  |  |  |  |  |  |  |  |
| 1562012E |  | FY12 Travel (Installtn) |  | 247d | 2011-10-03 | 2012-09-28 | 1562011E | 20d | 0d | TRAVEL | 1,404 | CHUDAKOV | 1 | 1 | D | 07-024 |  | EUGENE C |  |  | 11-026 |  |  |  |  |  |  |  |  |  |  |  |  |  |  |  |  |  |  |  |  |  |
| 1562100ba |  | Install col cave vacuum FY12 |  | 31d | 2011-10-03 | 2011-11-14 | 1562100b | 433d | 0d | MECH ENG [14.59 h]; MECH DES [14.59 h]; MECH TECH [175.06 h] | 9,505.52 | CHUDAKOV | 1 | 1 | D | 07-024 |  | EUGENE C |  |  | 11-026 |  |  | 11-006 |  | APP | 12-021F |  |  |  |  |  |  |  | 12-001 |  |  |  |  |  |  |  |
| 1562240a |  | Fab Upstream Platform CDC #1 (Installtn) Expenses FY12 |  | 35d | 2011-10-03 | 2011-11-18 | 1562240 | 172d | 0d | PLABOR | 4,027.89 | CHUDAKOV | 1 | 1 | D | 07-024 |  | EUGENE C | 09-027 | 09-027 | 11-026 |  | 11-004 | 11-006 |  | APP | 12-021F | 09-014 |  | 1 | 10-042 | 12-054F |  |  | 12-001 |  |  |  |  |  |  |  |
| 1562425 |  | Evaluate Procurements 2011 (Installtn) |  | 44d | 2011-10-28 | 2012-01-09 | 1562423 FS+19d | 172d | 0d | MECH ENG [80 h]; MECH DES [40 h] | 7,536.4 | CHUDAKOV | 1 | 1 | D | 07-024 |  | EUGENE C | 09-027 | 09-027 | 11-026 |  | 11-004 | 11-006 |  |  | 12-021F | 09-014 |  |  |  | 12-054F |  | 2 |  |  |  |  |  |  |  |  |
| 1562130 |  | Install Collimator Mag Sweep # 1 (Installtn) |  | 21d | 2011-11-15 | 2011-12-15 | 1562100, 1562102, 1553100, 1562105, 1562100ba | 433d | 73d | MECH ENG [40 h]; PROCUREMENT<$50K 60; MECH TECH [240 h] | 28,680.48 | CHUDAKOV | 1 | 1 | D | 07-024 |  | EUGENE C |  |  | 11-026 |  | 11-004 | 11-006 |  | APP | 12-021F | 09-014 |  |  |  |  |  |  |  |  |  |  |  |  |  |  |
| 1562242 |  | Oversee installation for upstream platform |  | 20d | 2011-11-21 | 2011-12-20 | 1562240a, 1562240b | 172d | 152d | MECH TECH [160 h]; MECH ENG [80 h]; MECH DES [40 h] | 14,646.8 | CHUDAKOV | 1 | 1 | D | 07-024 |  | EUGENE C | 09-027 | 09-027 | 11-026 |  | 11-004 | 11-006 |  | APP | 12-021F | 09-014 |  | 1 | 10-042 | 12-054F |  |  |  |  |  |  |  |  |  |  |
| 1562110 |  | Proc Collimator #2 and Obtain SEG Blocks (Installtn) |  | 65d | 2012-01-05 | 2012-04-06 | 9-120M FS+60d | 360d | 0d | PROCUREMENT>$50K 69; MECH ENG [8 h]; MECH TECH [40 h] | 24,568.67 | CHUDAKOV | 1 | 1 | D | 07-024 |  | EUGENE C |  |  | 11-026 |  |  |  |  | APP | 12-021F | 09-014 |  |  |  |  |  |  |  |  |  |  |  |  |  |  |
| 1562394 |  | Prepare procurement packages for downstream platform |  | 38d | 2012-01-05 | 2012-02-29 | 9-120M FS+60d | 570d | 0d | MECH ENG [160 h]; MECH TECH [480 h]; MECH DES [160 h]; SCIENTIST [80 h] | 45,906.4 | CHUDAKOV | 1 | 1 | D | 07-024 |  | EUGENE C |  |  | 11-026 |  |  | 11-006 |  |  |  | 09-014 |  |  | 10-042 | 12-054F |  |  |  |  |  |  |  |  |  |  |
| 1562325 |  | Fab SOLENOID Platform #2 (Installtn) Original |  | 15d | 2012-01-10 | 2012-01-31 | 9-120M FS+62d, 1562425 | 456d | 0d | MECH TECH [63.16 h]; MECH ENG [15.79 h] | 3,914.02 | CHUDAKOV | 1 | 1 | D | 07-024 |  | EUGENE C | 09-027 | 09-027 | 11-026 |  | 11-004 | 11-006 |  | APP | 12-021 | 09-014 |  |  | 10-042 | 12-054F |  |  |  |  |  |  |  |  |  |  |
| 1562605LOE |  | Electrical power engineer support 2012 |  | 169d | 2012-02-01 | 2012-09-28 | 9-120M FS+78d | 20d | 0d | ELEC ENG [880 h] | 62,092.8 | CHUDAKOV | 1 | 1 | D |  |  | EUGENE C |  |  | 11-026 |  |  | 11-006 |  |  | 12-021 |  |  | 1 |  |  |  |  |  |  |  |  |  |  |  |  |
| 1562655 |  | Cable mock up trials |  | 100d | 2012-02-03 | 2012-06-26 | 9-120M FS+80d | 563d |  | MECH ENG [34 h]; MECH DES [34 h]; MECH TECH [136 h] | 10,065.7 | CHUDAKOV | 1 | 1 | D |  |  | EUGENE C |  |  | 11-026 |  |  | 11-006 |  |  | 12-021 |  |  | 1 |  |  |  |  |  |  |  |  |  |  |  |  |
| 1562660 |  | Tagger Gantry design |  | 65d | 2012-02-03 | 2012-05-04 | 9-120M FS+80d | 538d | 0d | MECH TECH [136 h]; MECH ENG [34 h]; MECH DES [34 h] | 10,065.7 | CHUDAKOV | 1 | 1 | D |  |  | EUGENE C |  |  | 11-026 |  |  | 11-006 |  |  | 12-021 |  |  | 1 |  |  |  |  |  |  |  |  |  |  |  |  |
| 1562670 |  | Materials for installation Part A |  | 167d | 2012-02-03 | 2012-09-28 | 9-120M FS+80d | 496d |  | PROCUREMENT<$50K 60 | 47,500 | CHUDAKOV | 1 | 1 | D |  |  | EUGENE C |  |  | 11-026 |  |  | 11-006 |  |  | 12-021 |  |  | 1 |  |  | 12-055 |  |  |  |  |  |  |  |  |  |
| 1562670a |  | Materials for installation Part B |  | 167d | 2012-02-03 | 2012-09-28 | 9-120M FS+80d | 496d |  | PROCUREMENT<$50K 60 | 2,500 | CHUDAKOV | 1 | 1 | D |  |  | EUGENE C |  |  | 11-026 |  |  | 11-006 |  |  | 12-021 |  |  | 1 |  |  | 12-055 |  |  |  |  |  |  |  |  |  |
| 1562675 |  | Tagger LCW design |  | 65d | 2012-02-03 | 2012-05-04 | 9-120M FS+80d | 350d |  | MECH TECH [136 h]; MECH ENG [34 h]; MECH DES [34 h] | 10,065.7 | CHUDAKOV | 1 | 1 | D |  |  | EUGENE C |  |  | 11-026 |  |  | 11-006 |  |  | 12-021 |  |  | 1 |  |  |  |  |  |  |  |  |  |  |  |  |
| 1562680 |  | Fiducialize and survey equipment (2012) |  | 167d | 2012-02-03 | 2012-09-28 | 9-120M FS+80d | 268d | 0d | MECH TECH [170 h]; MECH ENG [34 h]; SUPPLIES & MATERIALS | 12,438.88 | CHUDAKOV | 1 | 1 | D |  |  | EUGENE C |  |  | 11-026 |  |  | 11-006 |  |  | 12-021 |  |  | 1 |  |  |  |  |  |  |  |  |  |  |  |  |
| 1562395 |  | Fab Downstream Platform #3 TOF, Fcal (Installtn) |  | 20d | 2012-03-01 | 2012-03-28 | 9-120M FS+93d, 1562394, 1562425 | 570d | 296d | PROCUREMENT>$50K 69; PLABOR; MECH ENG [40 h]; MECH TECH [80 h] | 82,410.39 | CHUDAKOV | 1 | 1 | D | 07-024 |  | EUGENE C | 09-027 | 09-027 | 11-026 |  |  | 11-006 |  | APP |  | 09-014 |  |  |  | 12-054F |  |  |  |  |  |  |  |  |  |  |
| 1562391 |  | Develop drift chamber gas system design |  | 80d | 2012-03-05 | 2012-06-26 | 9-120M FS+100d | 213d | 127d | MECH ENG [204 h]; MECH DES [306 h] | 29,044.5 | CHUDAKOV | 1 | 1 | D | 07-024 |  | EUGENE C |  |  | 11-026 |  |  | 11-006 |  |  | 12-021 | 09-014 |  |  | 10-042 | 12-054F |  |  |  |  |  |  |  |  |  |  |
| 1562325a |  | Fab SOLENOID Platform #2 (Installtn) Revised 2012 ETC Labor |  | 80d | 2012-03-29 | 2012-07-20 | 1562325 FS+40d | 476d | 202d | MECH ENG [24.21 h]; MECH TECH [96.84 h] | 6,001.18 | CHUDAKOV | 1 | 1 | D | 07-024 |  | EUGENE C | 09-027 | 09-027 | 11-026 |  | 11-004 | 11-006 |  | APP | 12-021 | 09-014 |  |  | 10-042 | 12-054F |  |  |  |  |  |  |  |  |  |  |
| 1562135 |  | Install Collimator #2 (Installtn) |  | 10d | 2012-04-09 | 2012-04-20 | 1562132, 1562110, 1562130 | 360d |  | MECH TECH [160 h]; PROCUREMENT<$50K 60; MECH ENG [40 h] | 27,465.29 | CHUDAKOV | 1 | 1 | D | 07-024 |  | EUGENE C |  |  | 11-026 |  | 11-004 |  |  | APP | 12-021F | 09-014 |  |  |  |  |  |  |  |  |  |  |  |  |  |  |
| 1562325b |  | Fab SOLENOID Platform #2 (Installtn) Revised 2012 ETC Procurement |  | 80d | 2012-04-26 | 2012-08-17 | 1562325 FS+60d | 456d | 182d | PROCUREMENT<$50K 60 | 40,950.21 | CHUDAKOV | 1 | 1 | D | 07-024 |  | EUGENE C | 09-027 | 09-027 | 11-026 |  | 11-004 | 11-006 |  | APP | 12-021 | 09-014 |  |  | 10-042 | 12-054F |  |  |  |  |  |  |  |  |  |  |
| 1562665 |  | Tagger Gantry Fab |  | 65d | 2012-04-30 | 2012-07-31 | 1562660 FS-5d | 538d |  | PROCUREMENT<$50K 60 | 42,000 | CHUDAKOV | 1 | 1 | D |  |  | EUGENE C |  |  | 11-026 |  |  | 11-006 |  |  | 12-021 |  |  | 1 |  |  |  |  |  |  |  |  |  |  |  |  |
| 1562185 |  | Install Racks Counting Room (Installtn) |  | 32d | 2012-05-04 | 2012-06-20 | 16332030, 9-120M FS+144d | 75d | 0d | PROCUREMENT<$50K 60; MECH TECH [160 h]; ELEC ENG [8 h] | 19,374.94 | CHUDAKOV | 1 | 1 | D | 07-024 |  | EUGENE C |  |  | 11-026 |  |  | 11-006 |  | APP | 12-021F | 09-014 |  |  |  |  |  |  |  | 10-059 |  |  |  |  |  |  |
| 1562115 |  | install Collimator Concrete Shielding (Installtn) |  | 44d | 2012-06-05 | 2012-08-03 | 9-120M FS+164d | 248d | 0d | MECH DES [40 h]; MECH TECH [200 h]; PROCUREMENT>$50K 69; MECH ENG [40 h] | 35,849.71 | CHUDAKOV | 1 | 1 | D | 07-024 |  | EUGENE C |  |  | 11-026 |  |  | 11-006 |  | APP | 12-021F |  |  |  |  |  |  |  |  |  |  |  |  |  |  |  |
| 1562359 |  | Install Temporary Platform #5 (Installtn) |  | 22d | 2012-06-15 | 2012-07-16 | 9-120M FS+172d | 301d |  | PROCUREMENT<$50K 60 | 58,500.29 | CHUDAKOV | 1 | 1 | D | 07-024 |  | EUGENE C |  |  | 11-026 |  |  | 11-006 |  | APP |  | 09-014 |  |  |  | 12-054F |  |  |  |  |  |  |  |  |  |  |
| 1562430 |  | Engineering Support for Tagger Installation 2012 (Installtn) |  | 73d | 2012-06-19 | 2012-09-28 | 9-120M FS+174d | 210d | 0d | MECH DES [1120 h]; MECH ENG [40 h] | 56,755.2 | CHUDAKOV | 1 | 1 | D | 07-024 |  | EUGENE C | 09-027 | 09-027 | 11-026 |  |  | 11-006 |  |  |  | 09-014 |  |  |  | 12-054F |  | 2 |  |  |  |  |  |  |  |  |
| 1562190 |  | Install Pwr to Racks Counting Room (Installtn) |  | 52d | 2012-06-21 | 2012-08-31 | 1562185 | 75d | 0d | PROCUREMENT>$50K 69 | 24,102.12 | CHUDAKOV | 1 | 1 | D | 07-024 |  | EUGENE C |  |  | 11-026 |  |  | 11-006 |  | APP | 12-021F | 09-014 |  |  |  |  |  |  |  | 10-059 |  |  |  |  |  |  |
| 1562125 |  | Install Primary Collimator (Installtn) |  | 40d | 2012-07-11 | 2012-09-05 | 1553080, 9-120M | 265d |  | MECH ENG [40 h]; PROCUREMENT<$50K 60; MECH TECH [240 h] | 27,510.46 | CHUDAKOV | 1 | 1 | D | 07-024 |  | EUGENE C |  |  | 11-026 |  | 11-004 |  |  | APP | 12-021F | 09-014 |  |  |  |  |  |  |  |  |  |  |  |  |  |  |
| 1562120 |  | Install Lead Shielding for Wall (Installtn) |  | 39d | 2012-08-06 | 2012-09-28 | 1562115, 9-120M FS+60d | 248d |  | MECH DES [120 h]; MECH TECH [320 h]; PROCUREMENT>$50K 69; MECH ENG [120 h] | 50,645.71 | CHUDAKOV | 1 | 1 | D | 07-024 |  | EUGENE C |  |  | 11-026 |  |  | 11-006 |  | APP | 12-021F |  |  |  |  |  |  |  |  |  |  |  |  |  |  |  |
| 1562055 |  | Install LCW Connections (Installtn) |  | 20d | 2012-08-22 | 2012-09-19 | 1562430 FS-47d, 1562050 FS-105d | 247d | 227d | MECH ENG [40 h]; PROCUREMENT<$50K 60; MECH TECH [200 h] | 20,892.8 | CHUDAKOV | 1 | 1 | D | 07-024 |  | EUGENE C |  |  | 11-026 |  |  | 11-006 |  | APP | 12-021 | 09-014 |  |  |  |  |  |  |  |  | 07-027 |  |  |  |  |  |
| 1562195 |  | Install Cooling to Racks in Counting Room (Installtn) |  | 44d | 2012-09-04 | 2012-11-02 | 1562190 | 75d | 0d | PROCUREMENT>$50K 69 NO ESCALATION FY13 | 3,510.01 | CHUDAKOV | 1 | 1 | D | 07-024 |  | EUGENE C |  |  | 11-026 |  |  | 11-006 |  | APP | 12-021F | 09-014 |  |  |  |  |  |  |  | 10-059 |  |  |  |  |  |  |
| 1562005LOE |  | FY13 Work Cordinator (Installtn) |  | 228d | 2012-10-01 | 2013-08-30 | 1562004LOE | 20d |  | MECH ENG [1618.06 h] | 117,082.82 | CHUDAKOV | 1 | 1 | D | 07-024 | E | EUGENE C | 09-027 | 09-027 | 11-026 |  |  |  |  |  |  |  |  |  |  |  |  |  |  |  |  | 13-014 |  |  |  |  |
| 1562013E |  | FY13 Travel (Installtn) |  | 228d | 2012-10-01 | 2013-08-30 | 1562012E | 20d |  | TRAVEL | 1,331.95 | CHUDAKOV | 1 | 1 | D | 07-024 |  | EUGENE C |  |  | 11-026 |  |  |  |  |  |  |  |  |  |  |  |  |  |  |  |  | 13-014 |  |  |  |  |
| 1562610LOE |  | Electrical power engineer support 2013 |  | 228d | 2012-10-01 | 2013-08-30 | 1562605LOE | 20d |  | ELEC ENG [1618.06 h] | 117,810.95 | CHUDAKOV | 1 | 1 | D |  |  | EUGENE C |  |  | 11-026 |  |  | 11-006 |  |  | 12-021 |  |  | 1 |  |  |  |  |  |  |  | 13-014 |  |  |  |  |
| 1562620 |  | Procure Electrical Power cable/conduit Part A |  | 120d | 2012-10-01 | 2013-03-29 | 9-130M | 351d | 0d | PROCUREMENT<$50K 60 | 4,127.6 | CHUDAKOV | 1 | 1 | D |  |  | EUGENE C |  |  | 11-026 |  |  | 11-006 |  |  | 12-021 |  |  | 1 |  |  | 12-055 |  |  |  |  |  |  |  |  |  |
| 1562620a |  | Procure Electrical Power cable/conduit Part B |  | 120d | 2012-10-01 | 2013-03-29 | 9-130M | 351d | 0d | PROCUREMENT<$50K 60 | 18,574.2 | CHUDAKOV | 1 | 1 | D |  |  | EUGENE C |  |  | 11-026 |  |  | 11-006 |  |  | 12-021 |  |  | 1 |  |  | 12-055 |  |  |  |  |  |  |  |  |  |
| 1562640 |  | Procure cable trays and hardware |  | 125d | 2012-10-01 | 2013-04-05 | 9-130M | 268d | 0d | PROCUREMENT<$50K 60 | 10,319 | CHUDAKOV | 1 | 1 | D |  |  | EUGENE C |  |  | 11-026 |  |  | 11-006 |  |  | 12-021 |  |  | 1 |  | 12-054 |  |  |  |  |  |  |  |  |  |  |
| 1562685 |  | Fiducialize and survey equipment (2013) |  | 228d | 2012-10-01 | 2013-08-30 | 1562680 | 268d |  | MECH TECH [156.29 h]; MECH ENG [31.26 h]; SUPPLIES & MATERIALS | 11,801.1 | CHUDAKOV | 1 | 1 | D |  |  | EUGENE C |  |  | 11-026 |  |  | 11-006 |  |  | 12-021 |  |  | 1 |  |  |  |  |  |  |  | 13-014 |  |  |  |  |
| 1562435 |  | Engineering Support for Detector Installation 2013 (Installtn) |  | 211d | 2012-10-24 | 2013-08-30 | 1562430 FS+17d | 210d | 190d | MECH ENG [36.54 h]; MECH DES [365.36 h] | 20,806 | CHUDAKOV | 1 | 1 | D | 07-024 |  | EUGENE C | 09-027 | 09-027 | 11-026 |  | 11-004 | 11-006 |  |  |  | 09-014 |  |  |  | 12-054F |  | 2 |  |  |  | 13-014 |  |  |  |  |
| 1562440 |  | Engineering Support for Tagger Installation 2013 (Installtn) |  | 207d | 2012-10-30 | 2013-08-30 | 9-130M FS+21d | 212d | 192d | MECH ENG [40 h]; MECH DES [400 h] | 22,778.4 | CHUDAKOV | 1 | 1 | D | 07-024 |  | EUGENE C | 09-027 | 09-027 | 11-026 |  |  | 11-006 |  |  |  | 09-014 |  |  |  |  |  | 2 |  |  |  |  |  |  |  |  |
| 1562200 |  | Install Fire Protection to Racks in Counting Room (Installtn) |  | 44d | 2012-11-05 | 2013-01-15 | 1562195 | 139d | 115d | PROCUREMENT>$50K 69 | 24,870.98 | CHUDAKOV | 1 | 1 | D | 07-024 |  | EUGENE C |  |  | 11-026 |  |  | 11-006 |  | APP | 12-021F | 09-014 |  |  |  | 12-054F |  |  |  | 10-059 | 07-027 |  |  |  |  |  |
| 1562050 |  | Install Tagger Pwr Supply (Installtn) |  | 38d | 2012-11-28 | 2013-01-29 | 1562430 FS-47d, 9-130M FS+40d | 247d | 0d | ELEC ENG [16 h]; ELEC TECH [480 h]; PROCUREMENT<$50K 60 | 35,097.45 | CHUDAKOV | 1 | 1 | D | 07-024 |  | EUGENE C |  |  | 11-026 |  |  | 11-006 |  | APP | 12-021 | 09-014 |  |  |  | 12-054 |  |  |  |  |  |  |  |  |  |  |
| 1562020M |  | Shipment of Bcal Modules (Installtn) | milestone | 0d | 2012-12-03 | 2012-12-03 | 1561105a | 166d | 146d |  |  | CHUDAKOV | 1 | 1 | D |  |  | EUGENE C |  |  | 11-026 |  |  | 11-006 |  |  | 12-021 |  |  |  |  |  |  |  |  |  |  |  | 6 | 09-043 |  |  |
| 1562625 |  | Install Electrical Power cable/conduit |  | 102d | 2012-12-03 | 2013-05-03 | 1562620 FS-77d, 1562620a FS-77d | 351d |  | MECH TECH [306 h] | 14,033.16 | CHUDAKOV | 1 | 1 | D |  |  | EUGENE C |  |  | 11-026 |  |  | 11-006 |  |  | 12-021 |  |  | 1 |  |  |  |  |  |  |  |  |  |  |  |  |
| 1562010M |  | Tagger Magnets Fabbed (Installtn) | milestone | 0d | 2012-12-04 | 2012-12-04 | 15511105 | 141d | 121d |  |  | CHUDAKOV | 1 | 1 | D |  |  | EUGENE C |  |  | 11-026 |  |  | 11-006 |  |  |  | 09-014 |  |  |  |  |  |  |  |  |  |  | 6 |  | 11-030 |  |
| 1562260 |  | Install Fire Protection (Installtn) Part A |  | 20d | 2012-12-04 | 2013-01-08 | 1562245 FS-81d | 306d | 0d | PROCUREMENT>$50K 69; PROCUREMENT<$50K 60 | 12,795.68 | CHUDAKOV | 1 | 1 | D | 07-024 |  | EUGENE C |  |  | 11-026 |  |  | 11-006 |  | APP |  | 09-014 |  |  |  | 12-054F | 12-055 |  |  |  |  |  |  |  |  | 11-044 |
| 1562260a |  | Install Fire Protection (Installtn) Part B |  | 20d | 2012-12-04 | 2013-01-08 | 1562245 FS-81d | 306d | 0d | PROCUREMENT>$50K 69 | 11,350.9 | CHUDAKOV | 1 | 1 | D | 07-024 |  | EUGENE C |  |  | 11-026 |  |  | 11-006 |  | APP |  | 09-014 |  |  |  | 12-054F | 12-055 |  |  |  |  |  |  |  |  | 11-044 |
| 1562392 |  | Procure final hardware for gas systems |  | 128d | 2013-01-03 | 2013-07-05 | 9-130M FS+60d, 1562391 | 86d | 0d | PROCUREMENT<$50K 60 | 44,935.3 | CHUDAKOV | 1 | 1 | D | 07-024 |  | EUGENE C |  |  | 11-026 |  |  | 11-006 |  |  | 12-021F | 09-014 |  |  | 10-042 | 12-054 |  |  |  |  |  |  |  |  |  |  |

| ID | Activity | Type | Duration | Start | Finish | Predecessors | Total float | Free float | Calendar | Resources | Cost | RESP - Responsibility | STRT%COMP for CM EVM | FNSH%COMP for CM EVM | 12 GeV 1st level Critical Path | HALL D Related Milestones | CAM RESPONSIBLE | CR 11-006 | CR 11-026 | CR 12-021 | CR 12-054 | CR 07-024 | CR 09-014 | CR 10-042 | CR 11-004 | CR 11-044 | Advance Purchase Plan > 500K | CR 13-014 | CR 07-027 | Milestone Level | CR 10-007 | CR 10-009 | CR 08-016 | CR 11-030 | CR 08-052 | CR 09-027 | CR 09-027 Repair | CR 11-054 | CR 12-055 | CR 09-045 | CR 11-049 | ReBaseline Actuals Adjustment | Original Activity ID Rebaseline | Over Under Fixed | EVMS Reporting Codes | BOE Expenses | CR 13-015 | Post Rebaseline | Obligated Prior to Rebaseline | BOE Labor | BOE Procurement | CR 13-007 | CR 11-040 | CR 09-012 | 12 GeV 2nd level Critical Path |
| --- | --- | --- | --- | --- | --- | --- | --- | --- | --- | --- | --- | --- | --- | --- | --- | --- | --- | --- | --- | --- | --- | --- | --- | --- | --- | --- | --- | --- | --- | --- | --- | --- | --- | --- | --- | --- | --- | --- | --- | --- | --- | --- | --- | --- | --- | --- | --- | --- | --- | --- | --- | --- | --- | --- | --- |
| 1562650 | Procure power transformers |  | 76d | 2013-02-01 | 2013-05-20 | 9-130M FS+80d | 340d |  |  | PROCUREMENT<$50K 60 | 17,542.3 | CHUDAKOV | 1 | 1 | 1 | D | EUGENE C | 11-006 | 11-026 | 12-021 | 12-054 |  |  |  |  |  |  |  |  |  |  |  |  |  |  |  |  |  |  |  |  |  |  |  |  |  |  |  |  |  |  |  |  |  |  |
| 1562393 | Install/test gas systems |  | 80d | 2013-02-05 | 2013-05-29 | 9-130M FS+2d, 1562392 FS-106d | 86d |  |  | MECH DES [136 h]; SCIENTIST [68 h]; MECH ENG [136 h]; MECH TECH [408 h] | 40,266.88 | CHUDAKOV | 1 | 1 |  | D | EUGENE C | 11-006 | 11-026 | 12-021 | 12-054 | 07-024 | 09-014 | 10-042 |  |  |  |  |  |  |  |  |  |  |  |  |  |  |  |  |  |  |  |  |  |  |  |  |  |  |  |  |  |  |  |
| 1562098 | Install Tagger Quad Stand & Magnet (Installtn) |  | 21d | 2013-03-01 | 2013-03-29 | 15511071, 15511035 FS+36d, 9-130M, 15511115 | 325d | 0d |  | MECH TECH [440 h] | 20,178.4 | CHUDAKOV | 1 | 1 |  | D | EUGENE C | 11-006 | 11-026 | 12-021F | 12-054 | 07-024 | 09-014 |  | 11-004 |  |  |  |  |  |  |  |  |  |  |  |  |  |  |  |  |  |  |  |  |  |  |  |  |  |  |  |  |  |  |
| 1562630 | Install nitrogen lines in hall D |  | 89d | 2013-03-04 | 2013-07-08 | 9-130M FS+100d | 307d |  |  | MECH TECH [289.2 h] | 13,262.71 | CHUDAKOV | 1 | 1 | 1 | D | EUGENE C | 11-006 | 11-026 | 12-021 |  |  |  |  |  |  |  |  |  |  |  |  |  |  |  |  |  |  |  |  |  |  |  |  |  |  |  |  |  |  |  |  |  |  |  |
| 1562085 | Racks - Install Tagger |  | 10d | 2013-03-11 | 2013-03-22 | 3C-10M FS+230d, 9-130M FS+105d | 40d | 0d |  | ELEC TECH [40 h] | 1,821.6 | CHUDAKOV | 1 | 1 |  | D | EUGENE C | 11-006 | 11-026 |  | 12-054 | 07-024 | 09-014 |  |  | 11-044 |  |  |  |  |  |  |  |  |  |  |  |  |  |  |  |  |  |  |  |  |  |  |  |  |  |  |  |  |  |
| 1562090 | Install Tagger Electrnc's (Installtn) |  | 10d | 2013-03-25 | 2013-04-05 | 1562085 | 123d |  |  | ELEC ENG [8 h]; ELEC TECH [240 h]; PLABOR | 16,341.39 | CHUDAKOV | 1 | 1 |  | D | EUGENE C | 11-006 | 11-026 |  | 12-054 | 07-024 | 09-014 |  |  | 11-044 |  |  |  |  |  |  |  |  |  |  |  |  |  |  |  |  |  |  |  |  |  |  |  |  |  |  |  |  |  |
| 1562245 | Racks - Install Hall Lower Level Upstream (U1) |  | 10d | 2013-03-25 | 2013-04-05 | 1544075, 1562085 | 103d | 0d |  | ELEC TECH [160 h] | 7,286.4 | CHUDAKOV | 1 | 1 | 1 | D | EUGENE C | 11-006 | 11-026 |  | 12-054 | 07-024 | 09-014 |  |  | 11-044 |  |  |  |  |  |  |  |  |  |  |  |  |  |  |  |  |  |  |  |  |  |  |  |  |  |  |  |  |  |
| 1562180 | Install Photon BL Tag Hall (Installtn) |  | 51d | 2013-04-01 | 2013-06-11 | 1562098 | 325d |  |  | PROCUREMENT<$50K 60; MECH TECH [120 h] | 8,521.53 | CHUDAKOV | 1 | 1 |  | D | EUGENE C | 11-006 | 11-026 | 12-021 | 12-054 | 07-024 | 09-014 |  | 11-004 |  | APP |  |  |  |  |  |  |  |  |  |  |  |  |  |  |  |  |  |  |  |  |  |  |  |  |  |  |  |  |
| 1562246 | Racks - Install Hall Lower Level Upstream South (US1) |  | 10d | 2013-04-08 | 2013-04-19 | 1562245 | 274d | 0d |  | ELEC TECH [80 h] | 3,643.2 | CHUDAKOV | 1 | 1 | 1 | D | EUGENE C | 11-006 | 11-026 |  | 12-054 | 07-024 | 09-014 |  |  | 11-044 |  |  |  |  |  |  |  |  |  |  |  |  |  |  |  |  |  |  |  |  |  |  |  |  |  |  |  |  |  |
| 1562250 | Install Pwr to Racks Platform #1 (Installtn) |  | 20d | 2013-04-08 | 2013-05-03 | 1562245 | 103d |  |  | ELEC TECH [320 h]; PROCUREMENT>$50K 69 | 37,512.05 | CHUDAKOV | 1 | 1 | 1 | D | EUGENE C | 11-006 | 11-026 |  | 12-054 | 07-024 | 09-014 |  |  | 11-044 | APP |  |  |  |  |  |  |  |  |  |  |  |  |  |  |  |  |  |  |  |  |  |  |  |  |  |  |  |  |
| 1562255 | Install Cooling to Racks Platform #1 (Installtn) |  | 20d | 2013-04-08 | 2013-05-03 | 1562245 | 103d |  |  | PROCUREMENT>$50K 69 | 36,219.88 | CHUDAKOV | 1 | 1 |  | D | EUGENE C | 11-006 | 11-026 |  | 12-054 |  | 09-014 |  |  | 11-044 | APP |  |  |  |  |  |  |  |  |  |  |  |  |  |  |  |  |  |  |  |  |  |  |  |  |  |  |  |  |
| 1562645 | Install cable trays and hardware |  | 96d | 2013-04-17 | 2013-08-30 | 1562640 FS+7d | 268d |  |  | MECH TECH [261.12 h] | 11,974.96 | CHUDAKOV | 1 | 1 | 1 | D | EUGENE C | 11-006 | 11-026 | 12-021 | 12-054 |  |  |  |  |  |  | 13-014 |  |  |  |  |  |  |  |  |  |  |  |  |  |  |  |  |  |  |  |  |  |  |  |  |  |  |  |
| 1562075 | Install Fire Protection for Tagger Electrnc's (Installtn) |  | 44d | 2013-04-19 | 2013-06-20 | 1562085 FS+19d | 40d | 0d |  | PROCUREMENT<$50K 60 | 25,353.92 | CHUDAKOV | 1 | 1 |  | D | EUGENE C | 11-006 | 11-026 | 12-021 | 12-054 | 07-024 | 09-014 |  |  | 11-044 | APP |  | 07-027 |  |  |  |  |  |  |  |  |  |  |  |  |  |  |  |  |  |  |  |  |  |  |  |  |  |  |
| 1562025M | Assy of Fcal (Installtn) | milestone | 0d | 2013-04-22 | 2013-04-22 | 15222004, 15222105 FS+10d | 44d | 0d |  |  |  | CHUDAKOV | 1 | 1 |  | D | EUGENE C | 11-006 | 11-026 |  | 12-054 |  | 09-014 | 10-042 |  |  |  |  |  | 6 | 10-007 | 10-009 |  |  |  |  |  |  |  |  |  |  |  |  |  |  |  |  |  |  |  |  |  |  |  |
| 1562247 | Racks - Install Hall Lower Level North (N1) |  | 8d | 2013-04-22 | 2013-05-01 | 1562246 | 274d | 0d |  | ELEC TECH [80 h] | 3,643.2 | CHUDAKOV | 1 | 1 | 1 | D | EUGENE C | 11-006 | 11-026 |  | 12-054 | 07-024 | 09-014 |  |  | 11-044 |  |  |  |  |  |  |  |  |  |  |  |  |  |  |  |  |  |  |  |  |  |  |  |  |  |  |  |  |  |
| 1562465 | Erect Dark Room for Fcal (Installtn) |  | 45d | 2013-04-22 | 2013-06-24 | 1562025M | 44d | 24d |  | MECH ENG [112 h]; PROCUREMENT<$50K 60; MECH TECH [480 h] | 32,531.79 | CHUDAKOV | 1 | 1 |  | D | EUGENE C | 11-006 | 11-026 |  | 12-054 | 07-024 | 09-014 | 10-042 |  |  | APP |  |  |  |  | 10-009 | 08-016 |  |  |  |  |  |  |  |  |  |  |  |  |  |  |  |  |  |  |  |  |  |  |
| 1562470 | Register Single Channel FCAL Detector to Readout (Installtn) |  | 65d | 2013-04-22 | 2013-07-23 | 15222105 FS+10d | 24d | 4d |  | MECH ENG [56 h]; MECH TECH [160 h] | 11,389.76 | CHUDAKOV | 1 | 1 |  | D | EUGENE C | 11-006 | 11-026 |  | 12-054 | 07-024 | 09-014 | 10-042 |  |  |  |  |  |  | 10-007 | 10-009 |  |  |  |  |  |  |  |  |  |  |  |  |  |  |  |  |  |  |  |  |  |  |  |
| 1562248 | Racks - Install Hall Lower Level South (S1) |  | 10d | 2013-05-02 | 2013-05-15 | 1562247 | 274d | 0d |  | ELEC TECH [80 h] | 3,643.2 | CHUDAKOV | 1 | 1 | 1 | D | EUGENE C | 11-006 | 11-026 |  | 12-054 | 07-024 | 09-014 |  |  | 11-044 |  |  |  |  |  |  |  |  |  |  |  |  |  |  |  |  |  |  |  |  |  |  |  |  |  |  |  |  |  |
| 1562635 | Install air lines in hall D |  | 84d | 2013-05-03 | 2013-08-30 | 9-130M FS+144d | 268d |  |  | MECH TECH [272.95 h] | 12,517.49 | CHUDAKOV | 1 | 1 | 1 | D | EUGENE C | 11-006 | 11-026 | 12-021 |  |  |  |  |  |  |  | 13-014 |  |  |  |  |  |  |  |  |  |  |  |  |  |  |  |  |  |  |  |  |  |  |  |  |  |  |  |
| 1562270 | Install Supprt Electrnc's, Platform #1 (Installtn) |  | 45d | 2013-05-06 | 2013-07-09 | 1562260a FS+81d, 1562260 FS+81d | 306d |  |  | ELEC TECH [240 h]; PLABOR | 19,380.9 | CHUDAKOV | 1 | 1 |  | D | EUGENE C | 11-006 | 11-026 |  | 12-054 | 07-024 | 09-014 | 10-042 |  | 11-044 |  |  | 07-027 |  |  |  |  |  |  |  |  |  |  |  |  |  |  |  |  |  |  |  |  |  |  |  |  |  |  |
| 1562360 | Install FDC on Platform (Installtn) |  | 10d | 2013-05-07 | 2013-05-20 | 1561140, 1561145 | 20d | 0d |  | MECH ENG [24 h]; PROCUREMENT<$50K 60; MECH TECH [120 h] | 10,861.82 | CHUDAKOV | 1 | 1 |  | D | EUGENE C | 11-006 | 11-026 |  | 12-054 | 07-024 | 09-014 | 10-042 |  |  | APP |  |  |  |  |  |  |  |  |  |  |  |  |  |  |  |  |  |  |  |  |  |  |  |  |  |  |  |  |
| 1562330 | Racks - Install Hall Upper Level Upstream (U2) |  | 10d | 2013-05-16 | 2013-05-30 | 1544075, 1562325, 1562325a, 1562248, 1562325b | 274d | 0d |  | ELEC TECH [160 h] | 7,286.4 | CHUDAKOV | 1 | 1 |  | D | EUGENE C | 11-006 | 11-026 |  | 12-054 | 07-024 | 09-014 |  |  | 11-044 | APP |  |  |  |  |  |  |  |  |  |  |  |  |  |  |  |  |  |  |  |  |  |  |  |  |  |  |  |  |
| 1562365 | Alignment of FDC (Installtn) |  | 10d | 2013-05-21 | 2013-06-04 | 1562360 | 20d | 0d |  | MECH ENG [40 h]; MECH TECH [120 h] | 8,397.6 | CHUDAKOV | 1 | 1 |  | D | EUGENE C | 11-006 | 11-026 |  | 12-054 | 07-024 | 09-014 | 10-042 |  |  |  |  |  |  |  |  |  |  |  |  |  |  |  |  |  |  |  |  |  |  |  |  |  |  |  |  |  |  |  |
| 1562335 | Install Pwr to Racks Platform #2 (Installtn) |  | 45d | 2013-05-31 | 2013-08-02 | 1562330 | 288d |  |  | PROCUREMENT>$50K 69 | 36,219.88 | CHUDAKOV | 1 | 1 |  | D | EUGENE C | 11-006 | 11-026 |  | 12-054 |  | 09-014 |  |  | 11-044 | APP |  |  |  |  |  |  |  |  |  |  |  |  |  |  |  |  |  |  |  |  |  |  |  |  |  |  |  |  |
| 1562045 | Install Tagger Magnets & Chamber (Installtn) |  | 45d | 2013-06-04 | 2013-08-06 | 1562010M, 1562430 FS-73d, 9-130M FS+165d, 3C-10M | 20d | 0d |  | MECH TECH [480 h]; PROCUREMENT<$50K 60; MECH ENG [160 h] | 64,980.95 | CHUDAKOV | 1 | 1 |  | D | EUGENE C | 11-006 | 11-026 |  | 12-054 | 07-024 | 09-014 |  |  |  | APP |  |  |  |  |  | 08-016 | 11-030 |  |  |  |  |  |  |  |  |  |  |  |  |  |  |  |  |  |  |  |  |  |
| 1562370 | Cables - Install on Trays Detector to Racks FDC |  | 62d | 2013-06-05 | 2013-08-30 | 1547170, 1562365, 1547160, 1547165 | 20d |  |  | ELEC TECH [228.92 h] | 10,425.02 | CHUDAKOV | 1 | 1 |  | D | EUGENE C | 11-006 | 11-026 | 12-021 | 12-054 | 07-024 | 09-014 | 10-042 |  |  | APP | 13-014 |  |  |  |  |  |  | 08-052 |  |  |  |  |  |  |  |  |  |  |  |  |  |  |  |  |  |  |  |  |
| 1562400 | Racks - Install Hall Upper Level Downstream (D2) |  | 10d | 2013-06-06 | 2013-06-19 | 1544075, 1562395, 1562330 FS+4d | 274d | 0d |  | ELEC TECH [160 h] | 7,286.4 | CHUDAKOV | 1 | 1 |  | D | EUGENE C | 11-006 | 11-026 |  | 12-054 | 07-024 | 09-014 |  |  | 11-044 |  |  |  |  |  |  |  |  |  |  |  |  |  |  |  |  |  |  |  |  |  |  |  |  |  |  |  |  |  |
| 1562405 | Install Pwr to Racks Platform #3 (Installtn) |  | 45d | 2013-06-20 | 2013-08-22 | 1562400 | 274d |  |  | PROCUREMENT<$50K 60 | 24,146.57 | CHUDAKOV | 1 | 1 |  | D | EUGENE C | 11-006 | 11-026 |  | 12-054 | 07-024 | 09-014 |  |  | 11-044 | APP |  |  |  |  |  |  |  |  |  |  |  |  |  |  |  |  |  |  |  |  |  |  |  |  |  |  |  |  |
| 1562070 | Install Cooling for Tagger Electrnc's (Installtn) |  | 10d | 2013-06-21 | 2013-07-05 | 1562075 | 40d | 0d |  | PROCUREMENT<$50K 60 | 3,621.98 | CHUDAKOV | 1 | 1 |  | D | EUGENE C | 11-006 | 11-026 | 12-021 | 12-054 |  | 09-014 |  |  | 11-044 | APP |  |  |  |  |  |  |  |  |  |  |  |  |  |  |  |  |  |  |  |  |  |  |  |  |  |  |  |  |
| 1562205 | Install Computers in Counting Room (Installtn) Part A |  | 20d | 2013-07-01 | 2013-07-29 | 1531057, 9-120M, 1531052, 1531032a, 1531018, 1531087, 1531042, 1531070, 1531012, 1531062, 1531047, 1531022, 1531077, 1531032, 1562200, 1531082, 1531048 | 24d | 0d |  | ELEC TECH [80 h]; SCIENTIST [80 h] | 9,472 | CHUDAKOV | 1 | 1 |  | D | EUGENE C | 11-006 | 11-026 | 12-021 | 12-054F | 07-024 |  | 10-042 |  |  | APP |  |  |  |  |  |  |  |  |  |  |  |  |  |  |  |  |  |  |  |  |  |  |  |  |  |  |  |  |
| 1562065 | Install Pwr for Tagger Electrnc's (Installtn) |  | 20d | 2013-07-08 | 2013-08-02 | 1562070 | 40d |  |  | PROCUREMENT<$50K 60 | 6,036.66 | CHUDAKOV | 1 | 1 |  | D | EUGENE C | 11-006 | 11-026 | 12-021 | 12-054 |  | 09-014 |  |  | 11-044 | APP |  |  |  |  |  |  |  |  |  |  |  |  |  |  |  |  |  |  |  |  |  |  |  |  |  |  |  |  |
| 1562225 | Mount Bcal Modules in Solenoid (Installtn) |  | 39d | 2013-07-09 | 2013-08-30 | 1561155, 15221155a, 1561155a FS+110d, 151173n, 15221155b, 15221180, 12361010, 15221156n, 1561155b, 1562020M, 15221180a, 1562435 FS-229d | 20d |  |  | MECH TECH [435 h]; MECH ENG [30 h]; MECH DES [30 h]; PROCUREMENT>$50K 69 | 23,611.2 | CHUDAKOV | 1 | 1 | 1 | D | EUGENE C | 11-006 | 11-026 | 12-021 | 12-054 | 07-024 | 09-014 | 10-042 | 11-004 |  | APP | 13-014 |  |  |  |  |  |  |  | 09-027 | 09-027 | 11-054 |  |  |  |  |  |  |  |  |  |  |  |  |  |  |  |  |  |
| 1562015M | Assy of CDC (Installtn) | milestone | 0d | 2013-07-16 | 2013-07-16 | 1561125 | 54d |  |  |  |  | CHUDAKOV | 1 | 1 |  | D | EUGENE C | 11-006 | 11-026 |  | 12-054F |  |  |  |  |  |  |  |  | 6 |  |  |  |  |  |  |  |  |  |  |  |  |  |  |  |  |  |  |  |  |  |  |  |  |  |
| 1562210 | Install Supprt Electrnc's in Counting Room (Installtn) |  | 20d | 2013-07-30 | 2013-08-26 | 1562205 | 24d |  |  | PLABOR | 12,073.29 | CHUDAKOV | 1 | 1 |  | D | EUGENE C | 11-006 | 11-026 | 12-021 | 12-054F | 07-024 |  | 10-042 |  |  |  |  |  |  |  |  |  |  |  |  |  |  |  |  |  |  |  |  |  |  |  |  |  |  |  |  |  |  |  |
| 1562475 | Cables - Install on Trays Detector to Racks FCAL |  | 24d | 2013-07-30 | 2013-08-30 | 1547200, 15222100a, 1562465, 1562470 | 20d |  |  | ELEC TECH [88.62 h] | 4,035.75 | CHUDAKOV | 1 | 1 |  | D | EUGENE C | 11-006 | 11-026 |  | 12-054F | 07-024 | 09-014 |  |  |  | APP | 13-014 |  |  |  |  |  |  |  |  |  |  |  |  |  |  |  |  |  |  |  |  |  |  |  |  |  |  |  |
| 1562060 | Survey & Align Magnets (Installtn) |  | 10d | 2013-08-07 | 2013-08-20 | 1562440 FS-210d, 1562045 | 20d | 0d |  | PLABOR; MECH TECH [400 h]; MECH ENG [40 h] | 45,384.97 | CHUDAKOV | 1 | 1 |  | D | EUGENE C | 11-006 | 11-026 |  | 12-054 | 07-024 | 09-014 |  |  |  |  |  |  |  |  |  |  | 11-030 |  |  |  |  |  |  |  |  |  |  |  |  |  |  |  |  |  |  |  |  |  |
| 1562275 | Cables - Install on Trays Detector to Racks BCAL |  | 10d | 2013-08-19 | 2013-08-30 | 1547175, 1547185 FS+8d, 1547180 | 20d |  |  | ELEC TECH [73.85 h] | 3,363.13 | CHUDAKOV | 1 | 1 | 1 | D | EUGENE C | 11-006 | 11-026 | 12-021 | 12-054 | 07-024 | 09-014 | 10-042 |  |  |  | 13-014 |  |  |  |  |  |  |  |  |  |  |  |  |  |  |  |  |  |  |  |  |  |  |  |  |  |  |  |
| 1562061 | Field Map Tagging Magnet (Installtn) |  | 8d | 2013-08-21 | 2013-08-30 | 1562055, 15511095a, 1562060, 1562045, 1562440 FS-200d, 15511095b | 20d |  |  | PD UNIV STUDNT [234.67 h] | 2,583.72 | CHUDAKOV | 1 | 1 |  | D | EUGENE C | 11-006 | 11-026 |  | 12-054 | 07-024 | 09-014 |  |  |  |  | 13-014 |  |  |  |  |  | 11-030 |  |  |  |  |  |  |  |  |  |  |  |  |  |  |  |  |  |  |  |  |  |
| 1562096 | Install Permanent Magnet Stand (Installtn) (Future Activity Complete prior to Rebaseline) |  | 1d | 2013-08-30 | 2013-08-30 | 9-130M FS+227d | 20d |  |  | MECH TECH |  | CHUDAKOV | 1 | 1 |  | D | EUGENE C | 11-006 | 11-026 | 12-021 |  | 07-024 | 09-014 |  |  |  |  | 13-014 |  |  |  |  |  |  |  |  |  |  |  |  |  |  |  |  |  |  |  |  |  |  |  |  |  |  |  |
| 1562097 | Install Permanent Magnet (Installtn) (Future Activity Complete prior to Rebaseline) |  | 1d | 2013-08-30 | 2013-08-30 | 9-130M FS+227d | 20d |  |  | MECH TECH |  | CHUDAKOV | 1 | 1 |  | D | EUGENE C | 11-006 | 11-026 | 12-021 |  | 07-024 | 09-014 |  |  |  |  | 13-014 |  |  |  |  |  |  |  |  |  |  |  |  |  |  |  |  |  |  |  |  |  |  |  |  |  |  |  |
| 1562140 | Install Collimator Concrete Shielding (Installtn) Part A (Future Activity Complete prior to Rebaseline) |  | 1d | 2013-08-30 | 2013-08-30 | 9-130M FS+227d | 20d |  |  | MECH TECH; MECH ENG; PROCUREMENT<$50K 60 |  | CHUDAKOV | 1 | 1 |  | D | EUGENE C | 11-006 | 11-026 | 12-021 | 12-054 | 07-024 | 09-014 |  |  |  | APP | 13-014 |  |  |  |  |  |  |  |  |  |  | 12-055 |  |  |  |  |  |  |  |  |  |  |  |  |  |  |  |  |
| 1562140a | Install Collimator Concrete Shielding (Installtn) Part B (Future Activity Complete prior to Rebaseline) |  | 1d | 2013-08-30 | 2013-08-30 | 9-130M FS+227d | 20d |  |  | PROCUREMENT<$50K 60 |  | CHUDAKOV | 1 | 1 |  | D | EUGENE C | 11-006 | 11-026 | 12-021 | 12-054 | 07-024 | 09-014 |  |  |  | APP | 13-014 |  |  |  |  |  |  |  |  |  |  | 12-055 |  |  |  |  |  |  |  |  |  |  |  |  |  |  |  |  |
| 1562145 | Install Collimator Lead Shielding Wall (Installtn) (Future Activity Complete prior to Rebaseline) |  | 1d | 2013-08-30 | 2013-08-30 | 9-130M FS+227d | 20d |  |  | MECH ENG; MECH TECH; PROCUREMENT<$50K 60 |  | CHUDAKOV | 1 | 1 |  | D | EUGENE C | 11-006 | 11-026 | 12-021 | 12-054 | 07-024 | 09-014 |  |  |  | APP | 13-014 |  |  |  |  |  |  |  |  |  |  |  |  |  |  |  |  |  |  |  |  |  |  |  |  |  |  |  |
| 1562345 | Install Fire Protection (Installtn) (Future Activity Complete prior to Rebaseline) |  | 1d | 2013-08-30 | 2013-08-30 | 9-130M FS+227d | 20d |  |  | PROCUREMENT>$50K 69 |  | CHUDAKOV | 1 | 1 |  | D | EUGENE C | 11-006 | 11-026 |  | 12-054 | 07-024 | 09-014 |  |  | 11-044 | APP | 13-014 |  |  |  |  |  |  |  |  |  |  |  |  |  |  |  |  |  |  |  |  |  |  |  |  |  |  |  |
| 1562413 | Install Fire Protection (Installtn) (Future Activity Complete prior to Rebaseline) |  | 1d | 2013-08-30 | 2013-08-30 | 9-130M FS+227d | 20d |  |  | PROCUREMENT<$50K 60 |  | CHUDAKOV | 1 | 1 |  | D | EUGENE C | 11-006 | 11-026 |  | 12-054 | 07-024 | 09-014 |  |  | 11-044 | APP | 13-014 |  |  |  |  |  |  |  |  |  |  |  |  |  |  |  |  |  |  |  |  |  |  |  |  |  |  |  |
| 1562420 | Install Supprt Electrnc's Platform #3 (Installtn) (Future Activity Complete prior to Rebaseline) |  | 1d | 2013-08-30 | 2013-08-30 | 9-130M FS+227d | 20d |  |  | PLABOR; ELEC TECH |  | CHUDAKOV | 1 | 1 |  | D | EUGENE C | 11-006 | 11-026 | 12-021 | 12-054 | 07-024 |  |  |  |  |  | 13-014 | 07-027 |  |  |  |  |  |  |  |  |  |  | 09-045 | 11-049 |  |  |  |  |  |  |  |  |  |  |  |  |  |  |
| 1562690 | Re-Baseline Actuals Adjustment |  | 1d | 2013-08-30 | 2013-08-30 | 9-130M FS+227d | 20d |  |  | PROCUREMENT>$50K 69 NO ESCALATION | 397,786.01 | CHUDAKOV | 1 | 1 |  |  | EUGENE C |  |  |  |  |  |  |  |  |  |  | 13-014 |  |  |  |  |  |  |  |  |  |  |  |  |  | ADJ |  |  |  |  |  |  |  |  |  |  |  |  |  |
| 2562000 | Procured Labor (Bill Vulcan) |  | 20d | 2013-09-03 | 2013-09-30 | 9-130M FS+228d | 0d |  | 8/5 M-F w/JLAB Holidays ReBaseline | PROCUREMENT<$50K 60 | 2,607.7 | CHUDAKOV | 1 | 1 |  | D | EUGENE C |  | 11-026 |  |  | 07-024 |  |  |  |  |  |  |  |  |  |  |  |  |  |  |  |  |  |  |  |  | 2562013E | y | E | PE | 13-015 | PR | OB |  |  |  |  |  |  |
| 2562005LOE | FY13 Work Cordinator (Installtn) |  | 20d | 2013-09-03 | 2013-09-30 | 9-130M FS+228d | 2d | 0d | 8/5 M-F w/JLAB Holidays ReBaseline | MECH ENG [141.88 h] | 10,266.44 | CHUDAKOV | 1 | 1 |  | D | EUGENE C |  | 11-026 |  |  | 07-024 |  |  |  |  |  |  |  |  |  |  |  |  |  | 09-027 | 09-027 |  |  |  |  |  | 2562005LOE |  | E |  | 13-015 | PR |  | PE |  |  |  |  |  |
| 2562013E | FY13 Travel (Installtn) |  | 20d | 2013-09-03 | 2013-09-30 | 9-130M FS+228d | 0d |  | 8/5 M-F w/JLAB Holidays ReBaseline | TRAVEL | 134.2 | CHUDAKOV | 1 | 1 |  | D | EUGENE C |  | 11-026 |  |  | 07-024 |  |  |  |  |  |  |  |  |  |  |  |  |  |  |  |  |  |  |  |  | 2562013E |  | E | PE | 13-015 | PR |  |  |  |  |  |  |  |
| 2562045 | Install Tagger Magnets & Chamber (Installtn) FY13 |  | 20d | 2013-09-03 | 2013-09-30 | 9-130M FS+228d | 124d | 0d | 8/5 M-F w/JLAB Holidays ReBaseline | MECH TECH [70.14 h]; MECH ENG [18.58 h]; SUPPLIES & MATERIALS; PLABOR; ELEC DES [1.86 h] | 7,592.02 | CHUDAKOV | 1 | 1 |  | D | EUGENE C | 11-006 | 11-026 |  | 12-054 | 07-024 | 09-014 |  |  |  | APP |  |  |  |  |  | 08-016 | 11-030 |  |  |  |  |  |  |  |  | 2562045 |  | S | EJ | 13-015 | PR |  | PE | EJ |  |  |  |  |
| 2562050 | Install Tagger Pwr Supply (Installtn) FY13 |  | 20d | 2013-09-03 | 2013-09-30 | 9-130M FS+228d | 44d | 0d | 8/5 M-F w/JLAB Holidays ReBaseline | ELEC ENG [5.6 h]; ELEC TECH [145.6 h]; SUPPLIES & MATERIALS; MECH TECH [21 h]; MECH ENG [8.4 h] | 9,965.49 | CHUDAKOV | 1 | 1 |  | D | EUGENE C | 11-006 | 11-026 | 12-021 | 12-054 | 07-024 | 09-014 |  |  |  | APP |  |  |  |  |  |  |  |  |  |  |  |  |  |  |  | 2562050 |  | S | EJ | 13-015 | PR |  | PE |  |  |  |  |  |
| 2562063 | Fab field map fixture tagging magnet |  | 32d | 2013-09-03 | 2013-10-16 | 9-130M FS+228d | 144d | 20d | 8/5 M-F w/JLAB Holidays ReBaseline | PROCUREMENT<$50K 60 NO ESCALATION FY14 | 1,840 | CHUDAKOV | 1 | 1 |  | D | EUGENE C |  |  |  |  |  |  |  |  |  |  |  |  |  |  |  |  |  |  |  |  |  |  |  |  |  | 2562063 |  | D |  | 13-015 | PR |  |  | EJ | 13-007 |  |  |  |
| 2562085 | Racks - Install Tagger FY13 |  | 20d | 2013-09-03 | 2013-09-30 | 9-130M FS+228d | 169d | 0d | 8/5 M-F w/JLAB Holidays ReBaseline | ELEC TECH [0.83 h]; SUPPLIES & MATERIALS; MECH TECH [7.45 h] | 400.15 | CHUDAKOV | 1 | 1 |  | D | EUGENE C | 11-006 | 11-026 |  | 12-054 | 07-024 | 09-014 |  |  | 11-044 |  |  |  |  |  |  |  |  |  |  |  |  |  |  |  |  | 2562085 |  | S | EJ | 13-015 | PR |  | PE |  | 13-007F |  |  |  |
| 2562099 | Cables - Install on Trays Detector to Racks Pair Spectrometer |  | 14d | 2013-09-03 | 2013-09-20 | 9-130M FS+228d | 215d | 65d | 8/5 M-F w/JLAB Holidays ReBaseline | SCIENTIST; ELEC TECH [80 h] | 3,643.2 | CHUDAKOV | 1 | 1 |  | D | EUGENE C | 11-006 | 11-026 | 12-021 |  | 07-024 | 09-014 |  |  |  |  |  |  |  |  |  |  |  |  |  |  |  |  |  |  |  | 2562099 |  | U |  | 13-015 | PR |  | PE |  | 13-007 |  |  |  |
| 2562181 | Install Photon BL Colli. Cave (Installtn) - Procurement |  | 77d | 2013-09-03 | 2013-12-20 | 2553057a FS-175d, 2553057 FS-175d, 2553055 FS-130d | 190d |  | 8/5 M-F w/JLAB Holidays ReBaseline | MECH TECH; SUPPLIES & MATERIALS; MECH ENG; PROCUREMENT<$50K 60 NO ESCALATION FY14 | 1,750.63 | CHUDAKOV | 1 | 1 |  | D | EUGENE C | 11-006 | 11-026 | 12-021 | 12-054 | 07-024 | 09-014 |  |  |  | APP |  |  |  |  |  |  |  |  |  |  |  |  |  |  |  | 2562181 |  | S | EJ | 13-015 | PR |  | PE | PE | 13-007 |  |  |  |
| 2562181a | Install Photon BL Colli. Cave (Installtn) - Labor/Expenses FY13 |  | 20d | 2013-09-03 | 2013-09-30 | 2553055 FS-130d, 2553057a FS-175d, 2553057 FS-175d | 190d | 0d | 8/5 M-F w/JLAB Holidays ReBaseline | MECH TECH [18.08 h]; SUPPLIES & MATERIALS; MECH ENG [1.81 h] | 990.2 | CHUDAKOV | 1 | 1 |  | D | EUGENE C | 11-006 | 11-026 | 12-021 | 12-054 | 07-024 | 09-014 |  |  |  | APP |  |  |  |  |  |  |  |  |  |  |  |  |  |  |  | 2562181 |  | S | EJ | 13-015 | PR |  | PE | PE | 13-007 |  |  |  |
| 2562225 | Mount Bcal in Solenoid (Installtn) |  | 20d | 2013-09-03 | 2013-09-30 | 251195 FS-4d | 0d |  | 8/5 M-F w/JLAB Holidays ReBaseline | SUPPLIES & MATERIALS; MECH TECH [208 h]; MECH ENG [40 h]; MECH DES [40 h] | 17,421.68 | CHUDAKOV | 1 | 1 | 1 | D | EUGENE C | 11-006 | 11-026 | 12-021 | 12-054 | 07-024 | 09-014 | 10-042 | 11-004 |  | APP |  |  |  |  |  |  |  |  | 09-027 | 09-027 | 11-054 |  |  |  |  | 2562225 |  | S | EJ | 13-015 | PR |  | EJ |  | 13-007F |  |  |  |
| 2562230 | Attach readout wedges to the BCAL modules in situ (Installtn) FY13 |  | 20d | 2013-09-03 | 2013-09-30 | 2546362 FS-20d, 2562225 FS-25d | 179d | 0d | 8/5 M-F w/JLAB Holidays ReBaseline | MECH DES [11.69 h]; MECH TECH [122.33 h]; MECH ENG [11.69 h]; SUPPLIES & MATERIALS | 7,718.81 | CHUDAKOV | 1 | 1 | 1 | D | EUGENE C | 11-006 | 11-026 | 12-021 | 12-054 | 07-024 | 09-014 | 10-042 |  |  | APP |  |  |  |  |  | 08-016 |  |  |  |  | 11-054 |  |  |  |  | 2562230 |  | S | EJ | 13-015 | PR |  | PE |  | 13-007F | 11-040 |  |  |
| 2562250a | Install Pwr to Racks Upstream Platform (Installtn) - Labor FY13 |  | 20d | 2013-09-03 | 2013-09-30 | 2562245 FS-28d | 166d | 0d | 8/5 M-F w/JLAB Holidays ReBaseline | ELEC TECH [101.05 h] | 4,601.82 | CHUDAKOV | 1 | 1 | 1 | D | EUGENE C | 11-006 | 11-026 |  | 12-054 | 07-024 | 09-014 |  |  | 11-044 | APP |  |  |  |  |  |  |  |  |  |  |  |  |  |  |  | 2562250 |  | S |  | 13-015 | PR |  | PE | EJ | 13-007F |  |  |  |
| 2562330 | Racks - Install Hall Upper Level Upstream (U2) |  | 20d | 2013-09-03 | 2013-09-30 | 2562225 FS-20d | 179d | 0d | 8/5 M-F w/JLAB Holidays ReBaseline | ELEC TECH [2.4 h]; SUPPLIES & MATERIALS; MECH TECH [74.4 h]; MECH DES [4.8 h]; MECH ENG [2.4 h] | 3,993.55 | CHUDAKOV | 1 | 1 |  | D | EUGENE C | 11-006 | 11-026 |  | 12-054 | 07-024 | 09-014 |  |  | 11-044 | APP |  |  |  |  |  |  |  |  |  |  |  |  |  |  |  | 2562330 |  | S | EJ | 13-015 | PR |  | PE |  | 13-007F |  |  |  |
| 2562335 | Install Pwr to Racks Platform #2 (Installtn) - Procurement |  | 77d | 2013-09-03 | 2013-12-20 | 2562330 FS-20d | 190d |  | 8/5 M-F w/JLAB Holidays ReBaseline | ELEC ENG; MECH TECH; PROCUREMENT>$50K 69 NO ESCALATION FY14 | 29,338.1 | CHUDAKOV | 1 | 1 |  | D | EUGENE C | 11-006 | 11-026 |  | 12-054 |  | 09-014 |  |  | 11-044 | APP |  |  |  |  |  |  |  |  |  |  |  |  |  |  |  | 2562335 |  | S |  | 13-015 | PR |  | PE | EJ |  |  |  |  |
| 2562335a | Install Pwr to Racks Platform #2 (Installtn) - Labor FY13 |  | 20d | 2013-09-03 | 2013-09-30 | 2562330 FS-20d | 190d | 0d | 8/5 M-F w/JLAB Holidays ReBaseline | ELEC ENG [1.68 h]; MECH TECH [42.08 h] | 2,052.19 | CHUDAKOV | 1 | 1 |  | D | EUGENE C | 11-006 | 11-026 |  | 12-054 |  | 09-014 |  |  | 11-044 | APP |  |  |  |  |  |  |  |  |  |  |  |  |  |  |  | 2562335 |  | S |  | 13-015 | PR |  | PE | EJ |  |  |  |  |
| 2562355 | Install Supprt Electrnc's Platform #2 (Installtn) - Procurement |  | 45d | 2013-09-03 | 2013-11-04 | 9-130M FS+228d | 222d |  | 8/5 M-F w/JLAB Holidays ReBaseline | MECH TECH; PROCUREMENT<$50K 60 NO ESCALATION FY14 | 8,451.3 | CHUDAKOV | 1 | 1 |  | D | EUGENE C | 11-006 | 11-026 | 12-021 | 12-054 | 07-024 |  |  |  |  | APP |  | 07-027 |  |  |  |  |  |  |  |  |  |  | 09-045 | 11-049 |  | 2562355 |  | S |  | 13-015 | PR |  | EJ | EJ |  |  | 09-012 |  |
| 2562355a | Install Supprt Electrnc's Platform #2 (Installtn) - Labor FY13 |  | 20d | 2013-09-03 | 2013-09-30 | 9-130M FS+228d | 222d | 0d | 8/5 M-F w/JLAB Holidays ReBaseline | MECH TECH [106.67 h] | 4,891.89 | CHUDAKOV | 1 | 1 |  | D | EUGENE C | 11-006 | 11-026 | 12-021 | 12-054 | 07-024 |  |  |  |  | APP |  | 07-027 |  |  |  |  |  |  |  |  |  |  | 09-045 | 11-049 |  | 2562355 |  | S |  | 13-015 | PR |  | EJ | EJ |  |  | 09-012 |  |
| 2562392 | Procure final hardware for Drift Chamber gas systems (Previously Obligated) |  | 29d | 2013-09-03 | 2013-10-11 | 9-130M FS+228d | 47d | 0d | 8/5 M-F w/JLAB Holidays ReBaseline | PROCUREMENT<$50K 60 NO ESCALATION FY14 | 26,348 | CHUDAKOV | 1 | 1 |  | D | EUGENE C | 11-006 | 11-026 | 12-021F | 12-054 | 07-024 | 09-014 | 10-042 |  |  |  |  |  |  |  |  |  |  |  |  |  |  |  |  |  |  | 2562392 | y | D |  | 13-015 | PR | OB |  | EV | 13-007 |  |  |  |
| 2562392a | Procure final hardware for Drift Chamber gas systems |  | 29d | 2013-09-03 | 2013-10-11 | 9-130M FS+228d | 47d | 0d | 8/5 M-F w/JLAB Holidays ReBaseline | PROCUREMENT<$50K 60 NO ESCALATION FY14 | 26,852 | CHUDAKOV | 1 | 1 |  | D | EUGENE C | 11-006 | 11-026 | 12-021F | 12-054 | 07-024 | 09-014 | 10-042 |  |  |  |  |  |  |  |  |  |  |  |  |  |  |  |  |  |  | 2562392 |  | D |  | 13-015 | PR |  |  | EV | 13-007 |  |  |  |
| 2562405 | Install Pwr to FCAL/TOF Racks (Installtn) |  | 75d | 2013-09-03 | 2013-12-18 | 9-130M FS+228d | 0d |  | 8/5 M-F w/JLAB Holidays ReBaseline | PROCUREMENT<$50K 60 NO ESCALATION FY14 | 19,558.72 | CHUDAKOV | 1 | 1 |  | D | EUGENE C | 11-006 | 11-026 |  | 12-054 | 07-024 | 09-014 |  |  | 11-044 | APP |  |  |  |  |  |  |  |  |  |  |  |  |  |  |  | 2562405 |  | S |  | 13-015 | PR |  |  | PE | 13-007F |  |  |  |
| 2562435 | Engineering Support for Detector Installation 2013 (Installtn) |  | 20d | 2013-09-03 | 2013-09-30 | 9-130M FS+228d | 129d | 83d | 8/5 M-F w/JLAB Holidays ReBaseline | MECH ENG [28.45 h]; MECH DES [38.11 h] | 3,953.07 | CHUDAKOV | 1 | 1 |  | D | EUGENE C | 11-006 | 11-026 |  | 12-054F | 07-024 | 09-014 |  | 11-004 |  |  |  |  |  |  |  |  |  |  | 09-027 | 09-027 |  |  |  |  |  | 2562435 |  | E |  | 13-015 | PR |  | PE |  | 13-007F |  |  | 2 |
| 2562440 | Engineering Support for Tagger Installation 2013 (Installtn) |  | 20d | 2013-09-03 | 2013-09-30 | 9-130M FS+228d | 231d | 23d | 8/5 M-F w/JLAB Holidays ReBaseline | MECH ENG [5.37 h]; MECH DES [32.21 h] | 1,989.7 | CHUDAKOV | 1 | 1 |  | D | EUGENE C | 11-006 | 11-026 |  |  | 07-024 | 09-014 |  |  |  |  |  |  |  |  |  |  |  |  | 09-027 | 09-027 |  |  |  |  |  | 2562440 |  | E |  | 13-015 | PR |  | PE |  |  |  |  | 2 |

| ID | Activity | Duration | Start | Finish | Predecessors | Total float | Free float | Calendar | Resources | Cost | Original Activity ID Rebaseline | RESP - Responsibility | STRT%COMP for CM EVM | FNSH%COMP for CM EVM | 12 GeV 2nd level Critical Path | HALL D Related Milestones | CR 07-024 | EVMS Reporting Codes | CAM RESPONSIBLE | CR 09-014 | CR 09-027 | CR 09-027 Repair | CR 11-006 | CR 11-026 | BOE Labor | CR 13-015 | Post Rebaseline | Advance Purchase Plan > 500K | CR 08-016 | CR 10-009 | CR 10-042 | CR 12-054 | CR 13-007 | BOE Expenses | Over Under Fixed | 12 GeV 1st level Critical Path | CR 12-055 | BOE Procurement | Obligated Prior to Rebaseline | CR 12-021 | CR 11-044 | CR 14-001 | CR 11-030 | CR 11-040 | CR 11-054 | CR 07-027 | CR 09-012 | CR 09-045 | CR 11-049 | CR 11-004 |
| --- | --- | --- | --- | --- | --- | --- | --- | --- | --- | --- | --- | --- | --- | --- | --- | --- | --- | --- | --- | --- | --- | --- | --- | --- | --- | --- | --- | --- | --- | --- | --- | --- | --- | --- | --- | --- | --- | --- | --- | --- | --- | --- | --- | --- | --- | --- | --- | --- | --- | --- |
| 2562445 | Engineering Support for Installation 2013 (Installtn) | 20d | 2013-09-03 | 2013-09-30 | 9-130M FS+228d | 19d | 0d | 8/5 M-F w/JLAB Holidays ReBaseline | MECH DES [74.19 h]; MECH ENG [61.29 h] | 8,122.9 | 2562445 | CHUDAKOV | 1 | 1 | 2 | D | 07-024 | E | EUGENE C | 09-014 | 09-027 | 09-027 | 11-006 | 11-026 | PE | 13-015 | PR |  |  |  |  |  |  |  |  |  |  |  |  |  |  |  |  |  |  |  |  |  |  |  |
| 2562466 | Install Dark Room for Fcal (Installtn) | 20d | 2013-09-03 | 2013-09-30 | 9-130M FS+228d | 79d | 0d | 8/5 M-F w/JLAB Holidays ReBaseline | ELEC ENG [6.8 h]; MECH ENG [13.6 h]; MECH DES [6.8 h]; SUPPLIES & MATERIALS; MECH TECH [34 h] | 4,226.48 | 2562466 | CHUDAKOV | 1 | 1 |  | D | 07-024 | S | EUGENE C | 09-014 |  |  | 11-006 | 11-026 | EJ | 13-015 | PR | APP | 08-016 | 10-009 | 10-042 | 12-054 | 13-007 | EJ |  |  |  |  |  |  |  |  |  |  |  |  |  |  |  |  |
| 2562475 | Cables - Install on Trays Detector to Racks FCAL FY13 (FY14 @ 2562475d) | 20d | 2013-09-03 | 2013-09-30 | 2562466 FS-20d | 79d | 0d | 8/5 M-F w/JLAB Holidays ReBaseline | SCIENTIST; ELEC TECH [73.84 h]; MECH TECH [73.84 h] | 6,749.43 | 2562475 | CHUDAKOV | 1 | 1 |  | D | 07-024 | U | EUGENE C | 09-014 |  |  | 11-006 | 11-026 | PE | 13-015 | PR | APP |  |  |  | 12-054F | 13-007 |  |  |  |  |  |  |  |  |  |  |  |  |  |  |  |  |  |
| 2562475a | Cables - Route and Connect on Detector FCAL FY13 | 20d | 2013-09-03 | 2013-09-30 | 2562475d FS-26d, 2562475 FS-26d | 83d | 0d | 8/5 M-F w/JLAB Holidays ReBaseline | SCIENTIST; ELEC TECH [16.41 h]; MECH TECH [16.41 h] | 1,499.87 | 2562475a | CHUDAKOV | 1 | 1 |  | D | 07-024 | U | EUGENE C | 09-014 |  |  | 11-006 | 11-026 | PE | 13-015 | PR |  |  |  |  |  | 13-007 |  |  |  |  |  |  |  |  |  |  |  |  |  |  |  |  |  |
| 2562475b | Cables - Route on Racks FCAL FY13 | 20d | 2013-09-03 | 2013-09-30 | 2562475aa FS-39d, 2562475a FS-39d | 83d | 0d | 8/5 M-F w/JLAB Holidays ReBaseline | SCIENTIST; ELEC TECH [20.87 h] | 950.42 | 2562475b | CHUDAKOV | 1 | 1 |  | D | 07-024 | U | EUGENE C | 09-014 |  |  | 11-006 | 11-026 | PE | 13-015 | PR |  |  |  |  |  | 13-007 |  |  |  |  |  |  |  |  |  |  |  |  |  |  |  |  |  |
| 2562475c | Cables - Connect to Crate Electronics FCAL FY13 | 20d | 2013-09-03 | 2013-09-30 | 2562475b FS-46d, 2562475ba FS-46d | 83d | 0d | 8/5 M-F w/JLAB Holidays ReBaseline | ELEC ENG [5.16 h]; ELEC TECH [10.32 h] | 845.67 | 2562475c | CHUDAKOV | 1 | 1 |  | D | 07-024 | U | EUGENE C | 09-014 |  |  | 11-006 | 11-026 | PE | 13-015 | PR |  |  |  |  |  | 13-007 |  |  |  |  |  |  |  |  |  |  |  |  |  |  |  |  |  |
| 2562478 | FCAL DAQ and Trigger_Setup FY13 | 20d | 2013-09-03 | 2013-09-30 | 2562475c FS-62d, 2562475ca FS-62d | 83d | 0d | 8/5 M-F w/JLAB Holidays ReBaseline | ELEC TECH [6.84 h]; SCIENTIST [47.87 h]; MECH TECH [13.68 h] | 4,426.1 | 2562478 | CHUDAKOV | 1 | 1 |  | D | 07-024 | S | EUGENE C | 09-014 |  |  | 11-006 | 11-026 | EJ | 13-015 | PR |  |  |  |  |  | 13-007 |  |  |  |  |  |  |  |  |  |  |  |  |  |  |  |  |  |
| 2562480 | Install Pulsing Sys for Fcal (Installtn) FY13 | 20d | 2013-09-03 | 2013-09-30 | 25222085 FS-88d, 25222085a FS-88d, 25222090 FS-88d, 2562475 FS-26d, 2562475d FS-26d | 79d | 0d | 8/5 M-F w/JLAB Holidays ReBaseline | SUPPLIES & MATERIALS; SCIENTIST [4.65 h]; ELEC TECH [4.65 h]; MECH TECH [4.65 h] | 2,135.9 | 2562480 | CHUDAKOV | 1 | 1 |  | D | 07-024 | S | EUGENE C | 09-014 |  |  | 11-006 | 11-026 | EJ | 13-015 | PR |  |  |  |  | 12-054F | 13-007 | EJ |  |  |  |  |  |  |  |  |  |  |  |  |  |  |  |  |
| 2562482 | Test and analyze FCAL detector FY13 | 20d | 2013-09-03 | 2013-09-30 | 2562478a FS-117d, 2562478 FS-117d | 83d | 0d | 8/5 M-F w/JLAB Holidays ReBaseline | SCIENTIST [30.43 h] | 2,217.13 | 2562482 | CHUDAKOV | 1 | 1 |  | D | 07-024 | S | EUGENE C | 09-014 |  |  | 11-006 | 11-026 | EJ | 13-015 | PR |  |  |  |  | 12-054F | 13-007 |  |  |  |  |  |  |  |  |  |  |  |  |  |  |  |  |  |
| 2562595a | Installation work space infrastructure (TW's Doublewide) | 267d | 2013-09-03 | 2014-09-30 | 9-130M FS+228d | 0d |  | 8/5 M-F w/JLAB Holidays ReBaseline | PROCUREMENT<$50K 60 NO ESCALATION | 5,800 | 2562595a | CHUDAKOV | 1 | 1 |  | D |  | E | EUGENE C |  |  |  | 11-006 | 11-026 |  | 13-015 | PR |  |  |  |  |  |  |  | y | 1 | 12-055 | OB | OB |  |  |  |  |  |  |  |  |  |  |  |
| 2562610LOE | Electrical power engineer support 2013 | 20d | 2013-09-03 | 2013-09-30 | 9-130M FS+228d | 245d | 0d | 8/5 M-F w/JLAB Holidays ReBaseline | ELEC ENG [141.91 h] | 10,332.47 | 2562610LOE | CHUDAKOV | 1 | 1 |  | D |  | E | EUGENE C |  |  |  | 11-006 | 11-026 | PE | 13-015 | PR |  |  |  |  |  |  |  |  | 1 |  |  |  | 12-021 |  |  |  |  |  |  |  |  |  |  |
| 2562620a | Procure Electrical Power cable/conduit Part B FY13 | 20d | 2013-09-03 | 2013-09-30 | 9-130M FS+228d | 230d | 0d | 8/5 M-F w/JLAB Holidays ReBaseline | SUPPLIES & MATERIALS | 24,064.17 | 2562620a | CHUDAKOV | 1 | 1 |  | D |  | D | EUGENE C |  |  |  | 11-006 | 11-026 |  | 13-015 | PR |  |  |  |  |  | 13-007 | CP |  | 1 | 12-055 |  |  | 12-021 |  |  |  |  |  |  |  |  |  |  |
| 2562626 | Install Transformers and Panels in Hall D | 62d | 2013-09-03 | 2013-11-27 | 9-130M FS+228d | 160d | 5d | 8/5 M-F w/JLAB Holidays ReBaseline | PROCUREMENT<$50K 60 NO ESCALATION FY14 | 43,349 | 2562626 | CHUDAKOV | 1 | 1 |  | D |  | D | EUGENE C |  |  |  | 11-006 | 11-026 |  | 13-015 | PR |  |  |  |  | 12-054 | 13-007 |  | y | 1 |  | PE | OB |  |  |  |  |  |  |  |  |  |  |  |
| 2562640 | Procure cable trays and hardware | 20d | 2013-09-03 | 2013-09-30 | 9-130M FS+228d | 124d | 0d | 8/5 M-F w/JLAB Holidays ReBaseline | PROCUREMENT<$50K 60 | 1,238.28 | 2562640 | CHUDAKOV | 1 | 1 |  | D |  | D | EUGENE C |  |  |  | 11-006 | 11-026 |  | 13-015 | PR |  |  |  |  | 12-054 |  |  |  | 1 |  | PE |  | 12-021 |  |  |  |  |  |  |  |  |  |  |
| 2562645 | Install cable trays and hardware FY13 | 20d | 2013-09-03 | 2013-09-30 | 2562640 FS-20d | 124d | 0d | 8/5 M-F w/JLAB Holidays ReBaseline | MECH TECH [28.21 h] | 1,293.71 | 2562645 | CHUDAKOV | 1 | 1 |  | D |  | S | EUGENE C |  |  |  | 11-006 | 11-026 | PE | 13-015 | PR |  |  |  |  | 12-054 |  |  |  | 1 |  |  |  | 12-021 |  |  |  |  |  |  |  |  |  |  |
| 2562685 | Fiducialize and survey equipment (2013) | 20d | 2013-09-03 | 2013-09-30 | 9-130M FS+228d | 247d |  | 8/5 M-F w/JLAB Holidays ReBaseline | MECH TECH [29.62 h]; MECH ENG [5.92 h]; SUPPLIES & MATERIALS | 2,236.33 | 2562685 | CHUDAKOV | 1 | 1 |  | D |  | S | EUGENE C |  |  |  | 11-006 | 11-026 | PE | 13-015 | PR |  |  |  |  |  |  | EJ |  | 1 |  |  |  | 12-021 |  |  |  |  |  |  |  |  |  |  |
| 2562690 | Manufacturing Drawings of cooling system for FCAL dark room FY13 | 20d | 2013-09-03 | 2013-09-30 | 9-130M FS+228d | 190d | 0d | 8/5 M-F w/JLAB Holidays ReBaseline | MECH ENG [4 h]; MECH DES [8.89 h] | 731.36 | 2562690 | CHUDAKOV | 1 | 1 |  | D |  | S | EUGENE C |  |  |  |  |  | PE | 13-015 | PR |  |  |  |  |  | 13-007 |  |  |  |  |  |  |  |  |  |  |  |  |  |  |  |  |  |
| 2562705 | Manufacturing Drawings of Chilled water system for Hall D | 12d | 2013-09-03 | 2013-09-18 | 9-130M FS+228d | 134d | 10d | 8/5 M-F w/JLAB Holidays ReBaseline | MECH ENG [68 h]; MECH DES [68 h] | 8,300.76 | 2562705 | CHUDAKOV | 1 | 1 |  | D |  | S | EUGENE C |  |  |  |  |  | PE | 13-015 | PR |  |  |  |  |  | 13-007 |  |  |  |  |  |  |  |  |  |  |  |  |  |  |  |  |  |
| 2562730 | Install Upstream cable trays (FDC/CDC/SC) FY13 | 20d | 2013-09-03 | 2013-09-30 | 2562225 FS-20d | 56d | 0d | 8/5 M-F w/JLAB Holidays ReBaseline | MECH DES [4.41 h]; MECH TECH [88.28 h]; MECH ENG [6.62 h] | 4,746.8 | 2562730 | CHUDAKOV | 1 | 1 |  | D |  | S | EUGENE C |  |  |  |  |  | PE | 13-015 | PR |  |  |  |  |  | 13-007 |  |  |  |  |  |  |  |  |  |  |  |  |  |  |  |  |  |
| 2562785 | Materials for install 2013 (Previously Obligated) | 20d | 2013-09-03 | 2013-09-30 | 9-130M FS+228d | 747d |  | 8/5 M-F w/JLAB Holidays ReBaseline | PROCUREMENT<$50K 60 | 3,757 | 2562785 | CHUDAKOV | 1 | 1 |  | D |  | E | EUGENE C |  |  |  |  |  |  | 13-015 | PR |  |  |  |  |  | 13-007 |  | y |  |  | PE | OB |  |  |  |  |  |  |  |  |  |  |  |
| 2562790 | Materials for install 2013 | 20d | 2013-09-03 | 2013-09-30 | 9-130M FS+228d | 747d |  | 8/5 M-F w/JLAB Holidays ReBaseline | PROCUREMENT<$50K 60 | 2,953 | 2562785 | CHUDAKOV | 1 | 1 |  | D |  | E | EUGENE C |  |  |  |  |  |  | 13-015 | PR |  |  |  |  |  | 13-007 |  | y |  |  | PE | OB |  |  |  |  |  |  |  |  |  |  |  |
| 2562830 | Install BCAL cooling manifold FY13 | 20d | 2013-09-03 | 2013-09-30 | 25221320 FS-23d | 29d | 0d | 8/5 M-F w/JLAB Holidays ReBaseline | MECH TECH [74.41 h]; MECH ENG [3.72 h]; MECH DES [3.72 h] | 3,866.55 | 2562830 | CHUDAKOV | 1 | 1 |  | D |  | S | EUGENE C |  |  |  |  |  | PE | 13-015 | PR |  |  |  |  |  | 13-007 |  |  |  |  |  |  |  |  |  |  |  |  |  |  |  |  |  |
| 2562865 | Procure lighting fixture under US platform | 24d | 2013-09-03 | 2013-10-04 | 9-130M FS+228d | 124d | 0d | 8/5 M-F w/JLAB Holidays ReBaseline | PROCUREMENT<$50K 60 NO ESCALATION FY14 | 550 | 2562865 | CHUDAKOV | 1 | 1 |  | D |  | D | EUGENE C |  |  |  |  |  |  | 13-015 | PR |  |  |  |  |  | 13-007 |  |  |  |  | PE |  |  |  |  |  |  |  |  |  |  |  |  |
| 2562895 | Preparing OSP ESAD documentation Rediness Review for April 14 Beam Run FY13 | 20d | 2013-09-03 | 2013-09-30 | 9-130M FS+228d | 97d | 0d | 8/5 M-F w/JLAB Holidays ReBaseline | MECH TECH [8.75 h]; MECH ENG [43.77 h]; SR STAFF [17.51 h]; SCIENTIST [51.77 h]; MECH DES [26.26 h]; ELEC ENG [13.13 h]; SUPPLIES & MATERIALS | 11,916.04 | 2562895 | CHUDAKOV | 1 | 1 |  | D |  | S | EUGENE C |  |  |  |  |  | PE | 13-015 | PR |  |  |  |  |  | 13-007 | PE |  |  |  |  |  |  |  |  |  |  |  |  |  |  |  |  |
| 2562805 | Manufacturing Drawings of N2 purge system FY13 | 18d | 2013-09-05 | 2013-09-30 | 9-130M FS+230d | 94d | 0d | 8/5 M-F w/JLAB Holidays ReBaseline | MECH ENG [56.47 h]; MECH DES [84.71 h] | 8,297.14 | 2562805 | CHUDAKOV | 1 | 1 |  | D |  | S | EUGENE C |  |  |  |  |  | PE | 13-015 | PR |  |  |  |  |  | 13-007 |  |  |  |  |  |  |  |  |  |  |  |  |  |  |  |  |  |
| 2562250 | Install Pwr to Racks Upstream Platform (Installtn) - Procurement | 57d | 2013-09-09 | 2013-11-26 | 2562245 FS-24d | 162d | 28d | 8/5 M-F w/JLAB Holidays ReBaseline | ELEC TECH; PROCUREMENT>$50K 69 NO ESCALATION FY14 | 20,645.33 | 2562250 | CHUDAKOV | 1 | 1 |  | D | 07-024 | S | EUGENE C | 09-014 |  |  | 11-006 | 11-026 | PE | 13-015 | PR | APP |  |  |  | 12-054 | 13-007F |  |  | 1 |  | EJ |  |  | 11-044 |  |  |  |  |  |  |  |  |  |
| 2562275 | Cables - Install on Trays Detector to Racks BCAL FY13 | 2d | 2013-09-27 | 2013-09-30 | 2547180 FS-2d, 2547175 FS-2d | 58d | 0d | 8/5 M-F w/JLAB Holidays ReBaseline | SCIENTIST; ELEC TECH [20 h]; MECH TECH [20 h] | 1,828 | 2562275 | CHUDAKOV | 1 | 1 |  | D | 07-024 | U | EUGENE C | 09-014 |  |  | 11-006 | 11-026 | PE | 13-015 | PR |  |  |  | 10-042 | 12-054 | 13-007 |  |  | 1 |  |  |  | 12-021 |  |  |  |  |  |  |  |  |  |  |
| 2562006LOE | FY14 Work Cordinator (Installtn) | 245d | 2013-10-01 | 2014-09-26 | 2562005LOE | 2d |  | 8/5 M-F w/JLAB Holidays ReBaseline | MECH ENG [1760 h] | 131,419.2 | 2562006LOE | CHUDAKOV | 1 | 1 |  | D | 07-024 | E | EUGENE C |  | 09-027 | 09-027 |  | 11-026 | PE | 13-015 | PR |  |  |  |  |  |  |  |  |  |  |  |  |  |  | 14-001 |  |  |  |  |  |  |  |  |
| 2562014E | FY14 Travel (Installtn) | 247d | 2013-10-01 | 2014-09-30 | 2562013E, 2562000 | 0d |  | 8/5 M-F w/JLAB Holidays ReBaseline | TRAVEL | 1,031.9 | 2562014E | CHUDAKOV | 1 | 1 |  | D | 07-024 | E | EUGENE C |  |  |  |  | 11-026 |  | 13-015 | PR |  |  |  |  |  |  | PE |  |  |  |  |  |  |  | 14-001 |  |  |  |  |  |  |  |  |
| 2562045a | Install Tagger Magnets & Chamber (Installtn) FY14 | 11d | 2013-10-01 | 2013-10-15 | 2562045, 9-130M FS+228d | 124d | 0d | 8/5 M-F w/JLAB Holidays ReBaseline | MECH TECH [38.58 h]; MECH ENG [10.22 h]; SUPPLIES & MATERIALS; PLABOR; ELEC DES [1.02 h] | 4,308.77 | 2562045 | CHUDAKOV | 1 | 1 |  | D | 07-024 | S | EUGENE C | 09-014 |  |  | 11-006 | 11-026 | PE | 13-015 | PR | APP | 08-016 |  |  | 12-054 |  | EJ |  |  |  | EJ |  |  |  | 14-001 | 11-030 |  |  |  |  |  |  |  |
| 2562050a | Install Tagger Pwr Supply (Installtn) FY14 | 8d | 2013-10-01 | 2013-10-10 | 9-130M FS+228d, 2562050 | 44d | 0d | 8/5 M-F w/JLAB Holidays ReBaseline | ELEC ENG [2.24 h]; ELEC TECH [58.24 h]; SUPPLIES & MATERIALS; MECH TECH [8.4 h]; MECH ENG [3.36 h] | 4,113.18 | 2562050 | CHUDAKOV | 1 | 1 |  | D | 07-024 | S | EUGENE C | 09-014 |  |  | 11-006 | 11-026 | PE | 13-015 | PR | APP |  |  |  | 12-054 |  | EJ |  |  |  |  |  | 12-021 |  | 14-001 |  |  |  |  |  |  |  |  |
| 2562061 | Field Map Tagging Magnet (Installtn) | 63d | 2013-10-01 | 2014-01-09 | 2562045a FS-11d, 2562050a FS-13d, 25511095a FS-12d, 2562050 FS-13d, 2562440 FS-200d, 25511095 FS-12d, 2562063 FS-32d, 2562845 FS-120d, 2562045 FS-11d | 124d | 57d | 8/5 M-F w/JLAB Holidays ReBaseline | MECH ENG [112.8 h]; MECH TECH [188 h]; SCIENTIST [75.2 h] | 22,972.48 | 2562061 | CHUDAKOV | 1 | 1 |  | D | 07-024 | S | EUGENE C | 09-014 |  |  | 11-006 | 11-026 | PE | 13-015 | PR |  |  |  |  | 12-054 | 13-007 |  |  |  |  |  |  |  |  | 14-001 | 11-030 |  |  |  |  |  |  |  |
| 2562085a | Racks - Install Tagger FY14 | 9d | 2013-10-01 | 2013-10-11 | 9-130M FS+228d, 2562085 | 169d | 53d | 8/5 M-F w/JLAB Holidays ReBaseline | ELEC TECH [0.37 h]; SUPPLIES & MATERIALS; MECH TECH [3.35 h] | 185.52 | 2562085 | CHUDAKOV | 1 | 1 |  | D | 07-024 | S | EUGENE C | 09-014 |  |  | 11-006 | 11-026 | PE | 13-015 | PR |  |  |  |  | 12-054 | 13-007F | EJ |  |  |  |  |  |  | 11-044 | 14-001 |  |  |  |  |  |  |  |  |
| 2562181b | Install Photon BL Colli. Cave (Installtn) - Labor/Expenses FY14 | 57d | 2013-10-01 | 2013-12-20 | 2562181a, 2553055 FS-130d, 2553057 FS-175d, 2553057a FS-175d | 190d |  | 8/5 M-F w/JLAB Holidays ReBaseline | MECH TECH [51.52 h]; SUPPLIES & MATERIALS; MECH ENG [5.15 h] | 2,911.14 | 2562181 | CHUDAKOV | 1 | 1 |  | D | 07-024 | S | EUGENE C | 09-014 |  |  | 11-006 | 11-026 | PE | 13-015 | PR | APP |  |  |  | 12-054 | 13-007 | EJ |  |  |  | PE |  | 12-021 |  | 14-001 |  |  |  |  |  |  |  |  |
| 2562230a | Attach readout wedges to the BCAL modules in situ (Installtn) FY14 | 57d | 2013-10-01 | 2013-12-20 | 2562225 FS-25d, 2562230, 2546362 FS-20d | 179d | 19d | 8/5 M-F w/JLAB Holidays ReBaseline | MECH DES [33.31 h]; MECH TECH [348.67 h]; MECH ENG [33.31 h]; SUPPLIES & MATERIALS | 22,700.36 | 2562230 | CHUDAKOV | 1 | 1 |  | D | 07-024 | S | EUGENE C | 09-014 |  |  | 11-006 | 11-026 | PE | 13-015 | PR | APP | 08-016 |  | 10-042 | 12-054 | 13-007F | EJ |  | 1 |  |  |  | 12-021 |  | 14-001 |  | 11-040 | 11-054 |  |  |  |  |  |
| 2562245 | Racks - Install Hall Lower Level Upstream (U1) | 8d | 2013-10-01 | 2013-10-10 | 9-140M, 2562225 FS-4d | 162d | 0d | 8/5 M-F w/JLAB Holidays ReBaseline | ELEC TECH [2 h]; MECH TECH [18 h] | 945.74 | 2562245 | CHUDAKOV | 1 | 1 |  | D | 07-024 | S | EUGENE C | 09-014 |  |  | 11-006 | 11-026 | PE | 13-015 | PR |  |  |  |  | 12-054 | 13-007F |  |  | 1 |  |  |  |  | 11-044 | 14-001 |  |  |  |  |  |  |  |  |
| 2562250b | Install Pwr to Racks Upstream Platform (Installtn) - Labor FY14 | 37d | 2013-10-01 | 2013-11-20 | 2562245 FS-24d, 2562250a | 166d | 32d | 8/5 M-F w/JLAB Holidays ReBaseline | ELEC TECH [186.95 h] | 8,784.78 | 2562250 | CHUDAKOV | 1 | 1 |  | D | 07-024 | S | EUGENE C | 09-014 |  |  | 11-006 | 11-026 | PE | 13-015 | PR | APP |  |  |  | 12-054 | 13-007F |  |  | 1 |  | EJ |  |  | 11-044 | 14-001 |  |  |  |  |  |  |  |  |
| 2562275d | Cables - Install on Trays Detector to Racks BCAL FY14 | 22d | 2013-10-01 | 2013-10-30 | 2547180 FS-2d, 2562275, 2547175 FS-2d | 58d | 0d | 8/5 M-F w/JLAB Holidays ReBaseline | SCIENTIST; ELEC TECH [220 h]; MECH TECH [220 h] | 20,748.2 | 2562275 | CHUDAKOV | 1 | 1 |  | D | 07-024 | U | EUGENE C | 09-014 |  |  | 11-006 | 11-026 | PE | 13-015 | PR |  |  |  | 10-042 | 12-054 | 13-007 |  |  | 1 |  |  |  | 12-021 |  | 14-001 |  |  |  |  |  |  |  |  |
| 2562335b | Install Pwr to Racks Platform #2 (Installtn) - Labor FY14 | 57d | 2013-10-01 | 2013-12-20 | 2562330 FS-21d, 2562335a | 190d |  | 8/5 M-F w/JLAB Holidays ReBaseline | ELEC ENG [4.8 h]; MECH TECH [119.92 h] | 6,035.15 | 2562335 | CHUDAKOV | 1 | 1 |  | D |  | S | EUGENE C | 09-014 |  |  | 11-006 | 11-026 | PE | 13-015 | PR | APP |  |  |  | 12-054 |  |  |  |  |  | EJ |  |  | 11-044 | 14-001 |  |  |  |  |  |  |  |  |
| 2562355b | Install Supprt Electrnc's Platform #2 (Installtn) - Labor FY14 | 25d | 2013-10-01 | 2013-11-04 | 2562355a, 9-130M FS+228d | 222d |  | 8/5 M-F w/JLAB Holidays ReBaseline | MECH TECH [133.34 h] | 6,309.65 | 2562355 | CHUDAKOV | 1 | 1 |  | D | 07-024 | S | EUGENE C |  |  |  | 11-006 | 11-026 | EJ | 13-015 | PR | APP |  |  |  | 12-054 |  |  |  |  |  | EJ |  | 12-021 |  | 14-001 |  |  |  | 07-027 | 09-012 | 09-045 | 11-049 |  |
| 2562445a | Engineering Support for Installation 2014 (Installtn) | 228d | 2013-10-01 | 2014-09-03 | 2562445, 9-130M FS+228d | 19d |  | 8/5 M-F w/JLAB Holidays ReBaseline | MECH DES [845.81 h]; MECH ENG [698.71 h] | 95,562.76 | 2562445 | CHUDAKOV | 1 | 1 | 2 | D | 07-024 | E | EUGENE C | 09-014 | 09-027 | 09-027 | 11-006 | 11-026 | PE | 13-015 | PR |  |  |  |  |  |  |  |  |  |  |  |  |  |  | 14-001 |  |  |  |  |  |  |  |  |
| 2562475aa | Cables - Route and Connect on Detector FCAL FY14 | 19d | 2013-10-01 | 2013-10-25 | 2562475a, 2562475 FS-26d, 2562475d FS-26d | 83d | 0d | 8/5 M-F w/JLAB Holidays ReBaseline | SCIENTIST; ELEC TECH [15.59 h]; MECH TECH [15.59 h] | 1,470.29 | 2562475a | CHUDAKOV | 1 | 1 |  | D | 07-024 | U | EUGENE C | 09-014 |  |  | 11-006 | 11-026 | PE | 13-015 | PR |  |  |  |  |  | 13-007 |  |  |  |  |  |  |  |  | 14-001 |  |  |  |  |  |  |  |  |
| 2562475ba | Cables - Route on Racks FCAL FY14 | 26d | 2013-10-01 | 2013-11-05 | 2562475b, 2562475a FS-39d, 2562475aa FS-39d | 83d | 0d | 8/5 M-F w/JLAB Holidays ReBaseline | SCIENTIST; ELEC TECH [27.13 h] | 1,274.84 | 2562475b | CHUDAKOV | 1 | 1 |  | D | 07-024 | U | EUGENE C | 09-014 |  |  | 11-006 | 11-026 | PE | 13-015 | PR |  |  |  |  |  | 13-007 |  |  |  |  |  |  |  |  | 14-001 |  |  |  |  |  |  |  |  |
| 2562475ca | Cables - Connect to Crate Electronics FCAL FY14 | 42d | 2013-10-01 | 2013-11-27 | 2562475b FS-46d, 2562475ba FS-46d, 2562475c | 83d | 0d | 8/5 M-F w/JLAB Holidays ReBaseline | ELEC ENG [10.84 h]; ELEC TECH [21.68 h] | 1,833.15 | 2562475c | CHUDAKOV | 1 | 1 |  | D | 07-024 | U | EUGENE C | 09-014 |  |  | 11-006 | 11-026 | PE | 13-015 | PR |  |  |  |  |  | 13-007 |  |  |  |  |  |  |  |  | 14-001 |  |  |  |  |  |  |  |  |
| 2562475d | Cables - Install on Trays Detector to Racks FCAL FY14 (FY13 @ 2562475) | 6d | 2013-10-01 | 2013-10-08 | 2562475, 2562466 FS-20d | 79d | 0d | 8/5 M-F w/JLAB Holidays ReBaseline | SCIENTIST; ELEC TECH [22.16 h]; MECH TECH [22.16 h] | 2,089.43 | 2562475 | CHUDAKOV | 1 | 1 |  | D | 07-024 | U | EUGENE C | 09-014 |  |  | 11-006 | 11-026 | PE | 13-015 | PR | APP |  |  |  | 12-054F | 13-007 |  |  |  |  |  |  |  |  | 14-001 |  |  |  |  |  |  |  |  |
| 2562478a | FCAL DAQ and Trigger_Setup FY14 | 97d | 2013-10-01 | 2014-02-27 | 2562475ca FS-62d, 2562478, 2562475c FS-62d | 83d | 0d | 8/5 M-F w/JLAB Holidays ReBaseline | ELEC TECH [33.16 h]; SCIENTIST [232.13 h]; MECH TECH [66.32 h] | 22,148.56 | 2562478 | CHUDAKOV | 1 | 1 |  | D | 07-024 | S | EUGENE C | 09-014 |  |  | 11-006 | 11-026 | EJ | 13-015 | PR |  |  |  |  |  | 13-007 |  |  |  |  |  |  |  |  | 14-001 |  |  |  |  |  |  |  |  |
| 2562480a | Install Pulsing Sys for Fcal (Installtn) FY14 | 109d | 2013-10-01 | 2014-03-17 | 25222085 FS-88d, 2562475d FS-26d, 25222085a FS-88d, 2562480, 2562475 FS-26d, 25222090 FS-88d | 79d | 15d | 8/5 M-F w/JLAB Holidays ReBaseline | SUPPLIES & MATERIALS; SCIENTIST [25.35 h]; ELEC TECH [25.35 h]; MECH TECH [25.35 h] | 12,013.03 | 2562480 | CHUDAKOV | 1 | 1 |  | D | 07-024 | S | EUGENE C | 09-014 |  |  | 11-006 | 11-026 | EJ | 13-015 | PR |  |  |  |  | 12-054F | 13-007 | EJ |  |  |  |  |  |  |  | 14-001 |  |  |  |  |  |  |  |  |
| 2562482a | Test and analyze FCAL detector FY14 | 164d | 2013-10-01 | 2014-06-03 | 2562478 FS-117d, 2562478a FS-117d, 2562482 | 83d |  | 8/5 M-F w/JLAB Holidays ReBaseline | SCIENTIST [249.57 h] | 18,762.67 | 2562482 | CHUDAKOV | 1 | 1 |  | D | 07-024 | S | EUGENE C | 09-014 |  |  | 11-006 | 11-026 | EJ | 13-015 | PR |  |  |  |  | 12-054F | 13-007 |  |  |  |  |  |  |  |  | 14-001 |  |  |  |  |  |  |  |  |
| 2562615LOE | Electrical power engineer support 2014 | 247d | 2013-10-01 | 2014-09-30 | 2562610LOE | 245d |  | 8/5 M-F w/JLAB Holidays ReBaseline | ELEC ENG [880 h] | 66,114.4 | 2562615LOE | CHUDAKOV | 1 | 1 |  | D |  | E | EUGENE C |  |  |  | 11-006 | 11-026 | PE | 13-015 | PR |  |  |  |  |  | 13-007 |  |  | 1 |  |  |  | 12-021 |  | 14-001 |  |  |  |  |  |  |  |  |
| 2562620aa | Procure Electrical Power cable/conduit Part B FY14 | 4d | 2013-10-01 | 2013-10-04 | 9-130M FS+228d, 2562620a | 230d | 75d | 8/5 M-F w/JLAB Holidays ReBaseline | SUPPLIES & MATERIALS | 4,966.36 | 2562620a | CHUDAKOV | 1 | 1 |  | D |  | D | EUGENE C |  |  |  | 11-006 | 11-026 |  | 13-015 | PR |  |  |  |  |  | 13-007 | CP |  | 1 | 12-055 |  |  | 12-021 |  | 14-001 |  |  |  |  |  |  |  |  |
| 2562645a | Install cable trays and hardware FY14 | 34d | 2013-10-01 | 2013-11-15 | 2562645, 2562640 FS-20d | 124d | 2d | 8/5 M-F w/JLAB Holidays ReBaseline | MECH TECH [47.95 h] | 2,268.99 | 2562645 | CHUDAKOV | 1 | 1 |  | D |  | S | EUGENE C |  |  |  | 11-006 | 11-026 | PE | 13-015 | PR |  |  |  |  | 12-054 |  |  |  | 1 |  |  |  | 12-021 |  | 14-001 |  |  |  |  |  |  |  |  |
| 2562690a | Manufacturing Drawings of cooling system for FCAL dark room FY14 | 16d | 2013-10-01 | 2013-10-22 | 2562690, 9-130M FS+228d | 190d | 0d | 8/5 M-F w/JLAB Holidays ReBaseline | MECH ENG [3.2 h]; MECH DES [7.11 h] | 603.68 | 2562690 | CHUDAKOV | 1 | 1 |  | D |  | S | EUGENE C |  |  |  |  |  | PE | 13-015 | PR |  |  |  |  |  | 13-007 |  |  |  |  |  |  |  |  | 14-001 |  |  |  |  |  |  |  |  |
| 2562730a | Install Upstream cable trays (FDC/CDC/SC) FY14 | 9d | 2013-10-01 | 2013-10-11 | 2562225 FS-20d, 2562730 | 56d | 53d | 8/5 M-F w/JLAB Holidays ReBaseline | MECH TECH [39.72 h]; MECH ENG [2.98 h]; MECH DES [1.99 h] | 2,204.12 | 2562730 | CHUDAKOV | 1 | 1 |  | D |  | S | EUGENE C |  |  |  |  |  | PE | 13-015 | PR |  |  |  |  |  | 13-007 |  |  |  |  |  |  |  |  | 14-001 |  |  |  |  |  |  |  |  |
| 2562805a | Manufacturing Drawings of N2 purge system FY14 | 33d | 2013-10-01 | 2013-11-14 | 9-130M FS+230d, 2562805 | 94d | 0d | 8/5 M-F w/JLAB Holidays ReBaseline | MECH ENG [103.53 h]; MECH DES [155.29 h] | 15,696.92 | 2562805 | CHUDAKOV | 1 | 1 |  | D |  | S | EUGENE C |  |  |  |  |  | PE | 13-015 | PR |  |  |  |  |  | 13-007 |  |  |  |  |  |  |  |  | 14-001 |  |  |  |  |  |  |  |  |
| 2562830a | Install BCAL cooling manifold FY14 | 20d | 2013-10-01 | 2013-10-28 | 25221320 FS-23d, 2562830 | 29d | 0d | 8/5 M-F w/JLAB Holidays ReBaseline | MECH TECH [74.41 h]; MECH ENG [3.72 h]; MECH DES [3.72 h] | 3,989.71 | 2562830 | CHUDAKOV | 1 | 1 |  | D |  | S | EUGENE C |  |  |  |  |  | PE | 13-015 | PR |  |  |  |  |  | 13-007 |  |  |  |  |  |  |  |  | 14-001 |  |  |  |  |  |  |  |  |
| 2562890 | Detector Readout Electronics Support Documentation and OSP | 248d | 2013-10-01 | 2014-10-01 | 9-140M | 10d | 0d | 8/5 M-F w/JLAB Holidays ReBaseline | ELEC ENG [640 h]; ELEC TECH [640 h]; SR STAFF [520 h] | 140,723.2 | 2562890 | CHUDAKOV | 1 | 1 |  | D |  | S | EUGENE C |  |  |  |  |  | PE | 13-015 | PR |  |  |  |  |  | 13-007 |  |  |  |  |  |  |  |  | 14-001 |  |  |  |  |  |  |  |  |
| 2562895a | Preparing OSP ESAD documentation Rediness Review for April 14 Beam Run FY14 | 150d | 2013-10-01 | 2014-05-13 | 2562895, 9-130M FS+228d | 97d |  | 8/5 M-F w/JLAB Holidays ReBaseline | MECH TECH [65.65 h]; MECH ENG [328.23 h]; SR STAFF [131.29 h]; SCIENTIST [388.23 h]; MECH DES [196.94 h]; ELEC ENG [98.47 h]; SUPPLIES & MATERIALS | 92,218.41 | 2562895 | CHUDAKOV | 1 | 1 |  | D |  | S | EUGENE C |  |  |  |  |  | PE | 13-015 | PR |  |  |  |  |  | 13-007 | PE |  |  |  |  |  |  |  | 14-001 |  |  |  |  |  |  |  |  |
| 2562231 | Manufacturing Drawings of BCAL Lateral support | 20d | 2013-10-03 | 2013-10-30 | 9-140M FS+2d | 160d | 0d | 8/5 M-F w/JLAB Holidays ReBaseline | MECH ENG [35.2 h]; MECH DES [52.8 h] | 5,337.02 | 2562231 | CHUDAKOV | 1 | 1 |  | D |  | S | EUGENE C |  |  |  |  |  | PE | 13-015 | PR |  |  |  |  |  | 13-007 |  |  |  |  |  |  |  |  | 14-001 |  |  |  |  |  |  |  |  |
| 2562710 | Procure Chilled water components | 33d | 2013-10-03 | 2013-11-18 | 9-140M FS+2d, 2562705 | 124d | 0d | 8/5 M-F w/JLAB Holidays ReBaseline | PROCUREMENT<$50K 60 | 10,112.62 | 2562710 | CHUDAKOV | 1 | 1 |  | D |  | D | EUGENE C |  |  |  |  |  |  | 13-015 | PR |  |  |  |  |  | 13-007 |  |  |  |  | EJ |  |  |  | 14-001 |  |  |  |  |  |  |  |  |
| 2562740 | Manufacturing Drawings of dry air cooling upstream racks/drift chambers | 30d | 2013-10-04 | 2013-11-14 | 9-140M FS+3d | 143d | 0d | 8/5 M-F w/JLAB Holidays ReBaseline | MECH ENG [200 h]; MECH DES [188 h] | 24,578.4 | 2562740 | CHUDAKOV | 1 | 1 |  | D |  | S | EUGENE C |  |  |  |  |  | PE | 13-015 | PR |  |  |  |  |  | 13-007 |  |  |  |  |  |  |  |  | 14-001 |  |  |  |  |  |  |  |  |
| 2562835 | Install PS shielding | 31d | 2013-10-04 | 2013-11-15 | 9-140M FS+3d | 213d |  | 8/5 M-F w/JLAB Holidays ReBaseline | MECH TECH [96 h]; MECH DES [4 h]; MECH ENG [4 h] | 5,046.6 | 2562835 | CHUDAKOV | 1 | 1 |  | D |  | H | EUGENE C |  |  |  |  |  | PE | 13-015 | PR |  |  |  |  |  | 13-007 |  |  |  |  |  |  |  |  | 14-001 |  |  |  |  |  |  |  |  |
| 2562360 | Install FDC on Platform (Installtn) | 6d | 2013-10-07 | 2013-10-14 | 2561145 FS-10d, 2561145a FS-10d, 2561140 FS-2d | 0d |  | 8/5 M-F w/JLAB Holidays ReBaseline | MECH ENG [24 h]; PROCUREMENT<$50K 60; MECH TECH [120 h] | 11,208 | 2562360 | CHUDAKOV | 1 | 1 |  | D | 07-024 | H | EUGENE C | 09-014 |  |  | 11-006 | 11-026 | EJ | 13-015 | PR | APP |  |  | 10-042 | 12-054 | 13-007 |  |  |  |  | EJ |  |  |  | 14-001 |  |  |  |  |  |  |  |  |
| 2562214 | Fab field map fixture for PS magnet | 49d | 2013-10-11 | 2013-12-20 | 9-140M FS+8d | 158d | 0d | 8/5 M-F w/JLAB Holidays ReBaseline | PROCUREMENT<$50K 60 | 6,593.84 | 2562214 | CHUDAKOV | 1 | 1 |  | D |  | D | EUGENE C |  |  |  |  |  |  | 13-015 | PR | APP |  |  |  |  | 13-007 |  |  | 1 |  | PE |  |  |  | 14-001 |  |  |  |  |  |  |  |  |
| 2562365 | Alignment of FDC (Installtn) | 7d | 2013-10-15 | 2013-10-23 | 2562360 | 0d |  | 8/5 M-F w/JLAB Holidays ReBaseline | MECH ENG [40 h]; MECH TECH [120 h] | 8,665.2 | 2562365 | CHUDAKOV | 1 | 1 |  | D | 07-024 | H | EUGENE C | 09-014 |  |  | 11-006 | 11-026 | EJ | 13-015 | PR |  |  |  | 10-042 | 12-054 | 13-007 |  |  |  |  |  |  |  |  | 14-001 |  |  |  |  |  |  |  |  |
| 2562810 | Procure N2 purge system | 54d | 2013-10-15 | 2014-01-10 | 2562805 FS-23d, 2562805a FS-23d | 94d | 0d | 8/5 M-F w/JLAB Holidays ReBaseline | PROCUREMENT<$50K 60 | 5,572.26 | 2562810 | CHUDAKOV | 1 | 1 |  | D |  | D | EUGENE C |  |  |  |  |  |  | 13-015 | PR |  |  |  |  |  | 13-007 |  |  |  |  | EJ |  |  |  | 14-001 |  |  |  |  |  |  |  |  |
| 2562850 | Procure UPS system for critical controls | 67d | 2013-10-16 | 2014-01-31 | 9-140M FS+11d | 165d | 0d | 8/5 M-F w/JLAB Holidays ReBaseline | PROCUREMENT<$50K 60 | 4,746.74 | 2562850 | CHUDAKOV | 1 | 1 |  | D |  | D | EUGENE C |  |  |  |  |  |  | 13-015 | PR |  |  |  |  |  | 13-007 |  |  |  |  | EJ |  |  |  | 14-001 |  |  |  |  |  |  |  |  |
| 2562098 | Install Tagger Quad Stand & Magnet (Installtn) | 64d | 2013-10-18 | 2014-01-30 | 2562045 FS+2d, 2562045a FS+2d | 170d | 18d | 8/5 M-F w/JLAB Holidays ReBaseline | MECH TECH [168 h]; ELEC TECH [16 h]; MECH ENG [24 h] | 10,493.68 | 2562098 | CHUDAKOV | 1 | 1 |  | D | 07-024 | S | EUGENE C | 09-014 |  |  | 11-006 | 11-026 | PE | 13-015 | PR |  |  |  |  | 12-054 | 13-007 |  |  |  |  |  |  | 12-021F |  | 14-001 |  |  |  |  |  |  |  | 11-004 |
| 2562770 | Manufacturing Drawings of fixture for commissioning target | 52d | 2013-10-18 | 2014-01-13 | 9-140M FS+13d | 128d | 0d | 8/5 M-F w/JLAB Holidays ReBaseline | MECH ENG [160 h]; MECH DES [240 h] | 24,259.2 | 2562770 | CHUDAKOV | 1 | 1 |  | D |  | S | EUGENE C |  |  |  |  |  | PE | 13-015 | PR |  |  |  |  |  | 13-007 |  |  |  |  |  |  |  |  | 14-001 |  |  |  |  |  |  |  |  |
| 2562246 | Racks - Install Hall Lower Level Upstream South (US1) | 24d | 2013-10-21 | 2013-11-21 | 2562225 FS-19d, 2562245 FS+6d | 199d | 51d | 8/5 M-F w/JLAB Holidays ReBaseline | ELEC TECH [40 h]; MECH TECH [36 h] | 3,583.12 | 2562246 | CHUDAKOV | 1 | 1 |  | D | 07-024 | H | EUGENE C | 09-014 |  |  | 11-006 | 11-026 | PE | 13-015 | PR |  |  |  |  | 12-054 | 13-007F |  |  | 1 |  |  |  |  | 11-044 | 14-001 |  |  |  |  |  |  |  |  |
| 2562180 | Install Photon BL Tag Hall (Installtn) | 24d | 2013-10-22 | 2013-11-22 | 2562098 FS-80d, 2553175 FS-40d, 2553017 FS-1d | 208d |  | 8/5 M-F w/JLAB Holidays ReBaseline | MECH TECH [85.12 h]; SUPPLIES & MATERIALS; MECH ENG [11.2 h]; PROCUREMENT<$50K 60 | 6,723.93 | 2562180 | CHUDAKOV | 1 | 1 |  | D | 07-024 | S | EUGENE C | 09-014 |  |  | 11-006 | 11-026 | PE | 13-015 | PR | APP |  |  |  | 12-054 | 13-007 | EJ |  |  |  | PE |  | 12-021 |  | 14-001 |  |  |  |  |  |  |  | 11-004 |

| ID | Activity | Type | Duration | Start | Finish | Predecessors | Total float | Free float | Calendar | Resources | Cost | Original Activity ID Rebaseline | RESP - Responsibility | STRT%COMP for CM EVM | FNSH%COMP for CM EVM | HALL D Related Milestones | EVMS Reporting Codes | CAM RESPONSIBLE | CR 13-007 | BOE Procurement | CR 13-015 | Post Rebaseline | CR 14-001 | BOE Labor | CR 07-024 | CR 09-014 | CR 11-006 | CR 11-026 | CR 12-021 | CR 12-054 | CR 11-030 | CR 10-042 | BOE Expenses | CR 07-027 | CR 11-044 | Advance Purchase Plan > 500K | CR 08-052 | 12 GeV 1st level Critical Path | Milestone Level | CR 12-049 | CR 11-040 | CR 11-054 | CR 09-045 | CR 11-049 | CR 11-004 |
| --- | --- | --- | --- | --- | --- | --- | --- | --- | --- | --- | --- | --- | --- | --- | --- | --- | --- | --- | --- | --- | --- | --- | --- | --- | --- | --- | --- | --- | --- | --- | --- | --- | --- | --- | --- | --- | --- | --- | --- | --- | --- | --- | --- | --- | --- |
| 2562745 | Fabricate dry air cooling system up racks/drift chambers |  | 28d | 2013-10-22 | 2013-12-02 | 2562740 FS-18d | 143d | 19d | 8/5 M-F w/JLAB Holidays ReBaseline | PROCUREMENT<$50K 60 | 8,306.8 | 2562745 | CHUDAKOV | 1 | 1 | D | S | EUGENE C | 13-007 | EJ | 13-015 | PR | 14-001 |  |  |  |  |  |  |  |  |  |  |  |  |  |  |  |  |  |  |  |  |  |  |
| 2562700 | Install Cooling system for FCAL dark room |  | 21d | 2013-10-23 | 2013-11-20 | 9-140M FS+13d, 2562690, 2562690a | 190d | 5d | 8/5 M-F w/JLAB Holidays ReBaseline | MECH TECH [120 h]; MECH ENG [8 h] | 6,275.76 | 2562700 | CHUDAKOV | 1 | 1 | D | S | EUGENE C | 13-007 |  | 13-015 | PR | 14-001 | EJ |  |  |  |  |  |  |  |  |  |  |  |  |  |  |  |  |  |  |  |  |  |
| 2562715 | Install Chilled water sytem Hall D |  | 46d | 2013-10-24 | 2014-01-09 | 2562710 FS-18d | 124d | 32d | 8/5 M-F w/JLAB Holidays ReBaseline | MECH TECH [288 h]; MECH ENG [8 h]; MECH DES [8 h] | 14,635.92 | 2562715 | CHUDAKOV | 1 | 1 | D | S | EUGENE C | 13-007 |  | 13-015 | PR | 14-001 | PE |  |  |  |  |  |  |  |  |  |  |  |  |  |  |  |  |  |  |  |  |  |
| 2562232 | Fab BCAL lateral support |  | 22d | 2013-10-28 | 2013-11-26 | 2562231 FS-3d | 160d | 0d | 8/5 M-F w/JLAB Holidays ReBaseline | PROCUREMENT<$50K 60 | 3,921.22 | 2562232 | CHUDAKOV | 1 | 1 | D | D | EUGENE C | 13-007 | PE | 13-015 | PR | 14-001 |  |  |  |  |  |  |  |  |  |  |  |  |  |  |  |  |  |  |  |  |  |  |
| 2562275a | Cables - Route and Connect on Detector BCAL |  | 28d | 2013-10-28 | 2013-12-06 | 2562275d FS-3d, 2562275 FS-3d | 63d | 0d | 8/5 M-F w/JLAB Holidays ReBaseline | SCIENTIST; ELEC TECH [160 h]; MECH TECH [160 h] | 15,089.6 | 2562275a | CHUDAKOV | 1 | 1 | D | U | EUGENE C | 13-007 |  | 13-015 | PR | 14-001 | PE | 07-024 | 09-014 | 11-006 | 11-026 | 12-021 | 12-054 |  |  |  |  |  |  |  |  |  |  |  |  |  |  |  |
| 2562060 | Survey & Align tagger beamline (Installtn) |  | 16d | 2013-11-01 | 2013-11-22 | 2562440, 2562045 FS+12d, 2562045a FS+12d | 208d | 190d | 8/5 M-F w/JLAB Holidays ReBaseline | MECH TECH [45.92 h]; MECH ENG [9.84 h] | 2,907.68 | 2562060 | CHUDAKOV | 1 | 1 | D | S | EUGENE C |  |  | 13-015 | PR | 14-001 | PE | 07-024 | 09-014 | 11-006 | 11-026 |  | 12-054 | 11-030 |  |  |  |  |  |  |  |  |  |  |  |  |  |  |
| 2562393 | Install/test gas systems |  | 52d | 2013-11-01 | 2014-01-28 | 2562392a FS-106d, 2562392 FS-106d, 9-140M FS+23d | 4d |  | 8/5 M-F w/JLAB Holidays ReBaseline | MECH DES [63.36 h]; SCIENTIST [119.68 h]; MECH ENG [63.36 h]; MECH TECH [1020.8 h]; SUPPLIES & MATERIALS | 65,828.1 | 2562393 | CHUDAKOV | 1 | 1 | D | S | EUGENE C | 13-007 |  | 13-015 | PR | 14-001 | EJ | 07-024 | 09-014 | 11-006 | 11-026 | 12-021 | 12-054 |  | 10-042 | EJ |  |  |  |  |  |  |  |  |  |  |  |  |
| 2562875 | Develop flammable gas detection system in solenoid |  | 46d | 2013-11-01 | 2014-01-17 | 9-140M FS+23d | 99d | 0d | 8/5 M-F w/JLAB Holidays ReBaseline | MECH ENG [156 h]; MECH DES [152 h] | 19,446.12 | 2562875 | CHUDAKOV | 1 | 1 | D | S | EUGENE C | 13-007 |  | 13-015 | PR | 14-001 | EJ |  |  |  |  |  |  |  |  |  |  |  |  |  |  |  |  |  |  |  |  |  |
| 2562270 | Install Supprt Electrnc's, Platform #1 (Installtn) |  | 43d | 2013-11-04 | 2014-01-15 | 9-140M FS+24d | 56d | 39d | 8/5 M-F w/JLAB Holidays ReBaseline | ELEC TECH [240 h]; PLABOR | 19,998.5 | 2562270 | CHUDAKOV | 1 | 1 | D | S | EUGENE C | 13-007F |  | 13-015 | PR | 14-001 | EJ | 07-024 | 09-014 | 11-006 | 11-026 |  | 12-054 |  | 10-042 | EJ | 07-027 | 11-044 |  |  |  |  |  |  |  |  |  |  |
| 2562370 | Cables - Install on Trays Detector to Racks FDC |  | 20d | 2013-11-04 | 2013-12-03 | 2547165, 2547170a, 2547165a, 2547170, 2562365 FS+7d | 0d |  | 8/5 M-F w/JLAB Holidays ReBaseline | ELEC TECH [120 h]; MECH TECH [160 h]; SCIENTIST | 13,210 | 2562370 | CHUDAKOV | 1 | 1 | D | U | EUGENE C | 13-007 |  | 13-015 | PR | 14-001 | PE | 07-024 | 09-014 | 11-006 | 11-026 | 12-021 | 12-054 |  | 10-042 |  |  |  | APP | 08-052 |  |  |  |  |  |  |  |  |
| 2562370a | Cables - Route and Connect on Detector FDC |  | 28d | 2013-11-04 | 2013-12-13 | 2562370 FS-20d | 3d | 0d | 8/5 M-F w/JLAB Holidays ReBaseline | ELEC TECH [240 h]; MECH TECH; SCIENTIST | 11,277.6 | 2562370a | CHUDAKOV | 1 | 1 | D | U | EUGENE C | 13-007 |  | 13-015 | PR | 14-001 | PE | 07-024 | 09-014 | 11-006 | 11-026 | 12-021 | 12-054 |  |  |  |  |  |  |  |  |  |  |  |  |  |  |  |
| 2562625 | Install Electrical Dirty Power cable/conduit from Panels |  | 68d | 2013-11-04 | 2014-02-20 | 2562626 FS-23d, 9-140M FS+24d, 2562620aa FS-55d, 2562620a FS-55d | 155d |  | 8/5 M-F w/JLAB Holidays ReBaseline | MECH TECH [306 h]; MECH ENG [12 h] | 15,375.96 | 2562625 | CHUDAKOV | 1 | 1 | D | S | EUGENE C |  |  | 13-015 | PR | 14-001 | PE |  |  | 11-006 | 11-026 | 12-021 |  |  |  |  |  |  |  |  | 1 |  |  |  |  |  |  |  |
| 2562840 | Install dirty power cable/conduit tagger |  | 33d | 2013-11-04 | 2013-12-20 | 9-140M FS+24d | 154d | 0d | 8/5 M-F w/JLAB Holidays ReBaseline | SUPPLIES & MATERIALS; MECH TECH [114 h] | 7,159.03 | 2562840 | CHUDAKOV | 1 | 1 | D | S | EUGENE C | 13-007 |  | 13-015 | PR | 14-001 | EJ |  |  |  |  |  |  |  |  | PE |  |  |  |  |  |  |  |  |  |  |  |  |
| 2562278 | BCAL DAQ Control and Trigger set-up |  | 41d | 2013-11-05 | 2014-01-14 | 2562275c FS-32d | 63d | 0d | 8/5 M-F w/JLAB Holidays ReBaseline | SCIENTIST [360 h] | 27,064.8 | 2562278 | CHUDAKOV | 1 | 1 | D | S | EUGENE C | 13-007 |  | 13-015 | PR | 14-001 | EJ | 07-024 | 09-014 | 11-006 | 11-026 | 12-021 | 12-054 |  |  |  |  |  |  |  |  |  |  |  |  |  |  |  |
| 2562880 | Procure flammable gas detection system |  | 53d | 2013-11-05 | 2014-01-31 | 2562875 FS-44d | 99d | 0d | 8/5 M-F w/JLAB Holidays ReBaseline | PROCUREMENT<$50K 60 | 8,461.58 | 2562880 | CHUDAKOV | 1 | 1 | D | D | EUGENE C | 13-007 | EJ | 13-015 | PR | 14-001 |  |  |  |  |  |  |  |  |  |  |  |  |  |  |  |  |  |  |  |  |  |  |
| 2562870 | Install lighting fixtures under US platform |  | 23d | 2013-11-12 | 2013-12-16 | 2562865 FS+26d | 124d | 0d | 8/5 M-F w/JLAB Holidays ReBaseline | MECH TECH [88 h] | 4,164.16 | 2562870 | CHUDAKOV | 1 | 1 | D | S | EUGENE C | 13-007 |  | 13-015 | PR | 14-001 | PE |  |  |  |  |  |  |  |  |  |  |  |  |  |  |  |  |  |  |  |  |  |
| 2562636 | Manufacture Drawing Inst Air Sys |  | 25d | 2013-11-15 | 2014-01-02 | 2562805, 2562805a | 159d | 0d | 8/5 M-F w/JLAB Holidays ReBaseline | MECH ENG [160 h]; MECH DES [240 h] | 24,259.2 | 2562636 | CHUDAKOV | 1 | 1 | D | S | EUGENE C |  |  | 13-015 | PR | 14-001 | PE |  |  | 11-006 | 11-026 | 12-021 |  |  |  |  |  |  |  |  | 1 |  |  |  |  |  |  |  |
| 2562275b | Cables - Route on Racks BCAL |  | 23d | 2013-11-18 | 2013-12-20 | 2562275a FS-13d | 63d | 0d | 8/5 M-F w/JLAB Holidays ReBaseline | SCIENTIST; ELEC TECH [80 h]; MECH TECH [40 h] | 5,652 | 2562275b | CHUDAKOV | 1 | 1 | D | U | EUGENE C | 13-007 |  | 13-015 | PR | 14-001 | PE | 07-024 | 09-014 | 11-006 | 11-026 | 12-021 | 12-054 |  |  |  |  |  |  |  |  |  |  |  |  |  |  |  |
| 2562205 | Install NIM and CAEN Crates in Counting Room (Installtn) |  | 20d | 2013-11-21 | 2013-12-20 | 2531070 FS-1d, 2531047, 2531077 | 17d | 0d | 8/5 M-F w/JLAB Holidays ReBaseline | ELEC TECH [80 h]; SCIENTIST [80 h] | 9,773.6 | 2562205 | CHUDAKOV | 1 | 1 | D | U | EUGENE C | 13-007F |  | 13-015 | PR | 14-001 | PE | 07-024 |  | 11-006 | 11-026 | 12-021 | 12-054F |  | 10-042 |  |  |  | APP |  |  |  |  |  |  |  |  |  |
| 2562275c | Cables - Connect to Crate Electronics BCAL |  | 18d | 2013-11-25 | 2013-12-20 | 2562275b FS-18d | 63d | 0d | 8/5 M-F w/JLAB Holidays ReBaseline | ELEC TECH [120 h]; ELEC ENG [40 h] | 8,644 | 2562275c | CHUDAKOV | 1 | 1 | D | U | EUGENE C | 13-007 |  | 13-015 | PR | 14-001 | PE | 07-024 | 09-014 | 11-006 | 11-026 | 12-021 | 12-054 |  |  |  |  |  |  |  |  |  |  |  |  |  |  |  |
| 2562035M | Assy of TOF (Installtn) | milestone | 0d | 2013-12-02 | 2013-12-02 | 2561060M | 163d | 99d | 8/5 M-F w/JLAB Holidays ReBaseline |  |  | 2562035M | CHUDAKOV | 1 | 1 | D | M | EUGENE C | 13-007F |  | 13-015 | PR |  |  |  | 09-014 | 11-006 | 11-026 | 12-021 | 12-054 |  |  |  |  |  |  |  |  | 6 | 12-049 |  |  |  |  |  |
| 2562535 | Crates - Loaded (VME64x VXS HV LV) Install Hall FDC |  | 50d | 2013-12-02 | 2014-02-20 | 9-140M FS+42d, 2548020a FS-46d, 2548025 FS-64d, 2548020 FS-46d, 2548025a FS-64d | 80d | 0d | 8/5 M-F w/JLAB Holidays ReBaseline | ELEC TECH [320 h] | 15,036.8 | 2562535 | CHUDAKOV | 1 | 1 | D | U | EUGENE C |  |  | 13-015 | PR | 14-001 | PE |  |  | 11-006 | 11-026 | 12-021 | 12-054 |  |  |  |  |  |  |  | 1 |  |  |  |  |  |  |  |
| 2562855 | Install UPS system for critical controls |  | 38d | 2013-12-04 | 2014-02-06 | 2562850 FS-34d | 165d |  | 8/5 M-F w/JLAB Holidays ReBaseline | MECH TECH [200 h] | 9,464 | 2562855 | CHUDAKOV | 1 | 1 | D | S | EUGENE C | 13-007 |  | 13-015 | PR | 14-001 | PE |  |  |  |  |  |  |  |  |  |  |  |  |  |  |  |  |  |  |  |  |  |
| 2562290 | Cables - Install on Trays Detector to Racks CDC |  | 6d | 2013-12-05 | 2013-12-12 | 2547135 FS+20d, 2562330 | 134d | 0d | 8/5 M-F w/JLAB Holidays ReBaseline | SCIENTIST; ELEC TECH [120 h]; MECH TECH [80 h] | 9,424.4 | 2562290 | CHUDAKOV | 1 | 1 | D | U | EUGENE C | 13-007 |  | 13-015 | PR | 14-001 | PE | 07-024 | 09-014 | 11-006 | 11-026 | 12-021 | 12-054 |  | 10-042 |  |  |  |  |  | 1 |  |  |  |  |  |  |  |
| 2562775 | Fab Fixture for commissioning target |  | 48d | 2013-12-05 | 2014-02-21 | 2562770 FS-20d | 128d | 0d | 8/5 M-F w/JLAB Holidays ReBaseline | PROCUREMENT<$50K 60 | 8,255.2 | 2562775 | CHUDAKOV | 1 | 1 | D | D | EUGENE C | 13-007 | PE | 13-015 | PR | 14-001 |  |  |  |  |  |  |  |  |  |  |  |  |  |  |  |  |  |  |  |  |  |  |
| 2562290a | Cables - Route and Connect on Detector CDC |  | 20d | 2013-12-09 | 2014-01-15 | 2562290 FS-4d | 134d | 0d | 8/5 M-F w/JLAB Holidays ReBaseline | SCIENTIST; ELEC TECH [200 h]; MECH TECH [120 h] | 15,076.4 | 2562290a | CHUDAKOV | 1 | 1 | D | U | EUGENE C | 13-007 |  | 13-015 | PR | 14-001 | PE | 07-024 | 09-014 | 11-006 | 11-026 | 12-021 | 12-054 |  |  |  |  |  |  |  |  |  |  |  |  |  |  |  |
| 2562370b | Cables - Route on Racks FDC |  | 14d | 2013-12-09 | 2014-01-07 | 2562370a FS-5d, 2562730a FS-15d, 2562730 FS-15d | 3d | 0d | 8/5 M-F w/JLAB Holidays ReBaseline | ELEC TECH [120 h]; MECH TECH [120 h]; SCIENTIST | 11,317.2 | 2562370b | CHUDAKOV | 1 | 1 | D | U | EUGENE C | 13-007 |  | 13-015 | PR | 14-001 | PE | 07-024 | 09-014 | 11-006 | 11-026 | 12-021 | 12-054 |  |  |  |  |  |  |  |  |  |  |  |  |  |  |  |
| 2562370c | Cables - Connect to Crate Electronics FDC |  | 48d | 2013-12-09 | 2014-02-25 | 2562370b FS-14d | 3d | 0d | 8/5 M-F w/JLAB Holidays ReBaseline | ELEC TECH [80 h]; MECH TECH; SCIENTIST; ELEC ENG [40 h] | 6,764.4 | 2562370c | CHUDAKOV | 1 | 1 | D | U | EUGENE C | 13-007 |  | 13-015 | PR | 14-001 | PE | 07-024 | 09-014 | 11-006 | 11-026 | 12-021 | 12-054 |  |  |  |  |  |  |  |  |  |  |  |  |  |  |  |
| 2562233 | Install BCAL lateral support |  | 24d | 2013-12-16 | 2014-01-29 | 2562232 FS+11d | 160d | 0d | 8/5 M-F w/JLAB Holidays ReBaseline | MECH TECH [80 h]; SUPPLIES & MATERIALS; MECH ENG [4 h] | 4,393.85 | 2562233 | CHUDAKOV | 1 | 1 | D | S | EUGENE C | 13-007 |  | 13-015 | PR | 14-001 | PE |  |  |  |  |  |  |  |  | EJ |  |  |  |  |  |  |  |  |  |  |  |  |
| 2562750 | Install dry air cooling system up racks/drift chamber |  | 32d | 2013-12-17 | 2014-02-11 | 2562870, 2562745 FS-9d | 124d | 0d | 8/5 M-F w/JLAB Holidays ReBaseline | MECH TECH [272 h]; MECH ENG [24 h] | 14,663.12 | 2562750 | CHUDAKOV | 1 | 1 | D | S | EUGENE C | 13-007 |  | 13-015 | PR | 14-001 | EJ |  |  |  |  |  |  |  |  |  |  |  |  |  |  |  |  |  |  |  |  |  |
| 2562206 | Install Computers in Counting Room (Installtn) Part B |  | 17d | 2014-01-02 | 2014-01-27 | 2562205, 2531022, 2531027 | 173d |  | 8/5 M-F w/JLAB Holidays ReBaseline | SCIENTIST [80 h]; ELEC TECH [80 h] | 9,773.6 | 2562206 | CHUDAKOV | 1 | 1 | D | U | EUGENE C |  |  | 13-015 | PR | 14-001 | PE | 07-024 |  | 11-006 | 11-026 | 12-021 |  |  | 10-042 |  |  |  | APP |  |  |  |  |  |  |  |  |  |
| 2562210 | Install Supprt Electrnc's in Counting Room (Installtn) |  | 20d | 2014-01-02 | 2014-01-30 | 2562205 | 17d | 0d | 8/5 M-F w/JLAB Holidays ReBaseline | PLABOR | 12,458.43 | 2562210 | CHUDAKOV | 1 | 1 | D | S | EUGENE C | 13-007 |  | 13-015 | PR | 14-001 |  | 07-024 |  | 11-006 | 11-026 | 12-021 | 12-054F |  | 10-042 | EJ |  |  |  |  |  |  |  |  |  |  |  |  |
| 2562216 | Field Map PS magnet |  | 32d | 2014-01-02 | 2014-02-17 | 2562214 | 158d |  | 8/5 M-F w/JLAB Holidays ReBaseline | MECH ENG [88 h]; MECH TECH [120 h] | 12,249.36 | 2562216 | CHUDAKOV | 1 | 1 | D | S | EUGENE C | 13-007 |  | 13-015 | PR | 14-001 | PE |  |  |  |  |  |  |  |  |  |  |  | APP |  | 1 |  |  |  |  |  |  |  |
| 2562530 | Crates - Loaded (VME64x VXS HV LV) Install Hall CDC |  | 26d | 2014-01-02 | 2014-02-07 | 2548020a, 2548020 | 126d | 2d | 8/5 M-F w/JLAB Holidays ReBaseline | ELEC TECH [160 h] | 7,518.4 | 2562530 | CHUDAKOV | 1 | 1 | D | U | EUGENE C |  |  | 13-015 | PR | 14-001 | PE |  |  | 11-006 | 11-026 | 12-021 | 12-054 |  |  |  |  |  |  |  | 1 |  |  |  |  |  |  |  |
| 2562845 | Install Power cable/conduit tagger |  | 33d | 2014-01-02 | 2014-02-18 | 2562840 | 154d | 30d | 8/5 M-F w/JLAB Holidays ReBaseline |  |  | 2562845 | CHUDAKOV | 1 | 1 | D | S | EUGENE C | 13-007 |  | 13-015 | PR |  |  |  |  |  |  |  |  |  |  |  |  |  |  |  |  |  |  |  |  |  |  |  |
| 2562637 | Procure Inst Air Sys |  | 30d | 2014-01-03 | 2014-02-14 | 2562636 | 159d |  | 8/5 M-F w/JLAB Holidays ReBaseline | SUPPLIES & MATERIALS | 4,746.74 | 2562637 | CHUDAKOV | 1 | 1 | D | D | EUGENE C |  |  | 13-015 | PR | 14-001 |  |  |  | 11-006 | 11-026 | 12-021 |  |  |  | EJ |  |  |  |  | 1 |  |  |  |  |  |  |  |
| 2562099a | Cables - Route and Connect on Detector Pair Spectrometer |  | 10d | 2014-01-06 | 2014-01-17 | 2562099, 9-140M FS+59d | 150d | 0d | 8/5 M-F w/JLAB Holidays ReBaseline | SCIENTIST; ELEC TECH [80 h] | 3,759.2 | 2562099a | CHUDAKOV | 1 | 1 | D | U | EUGENE C | 13-007 |  | 13-015 | PR | 14-001 | PE | 07-024 | 09-014 | 11-006 | 11-026 | 12-021 |  |  |  |  |  |  |  |  |  |  |  |  |  |  |  |  |
| 2562090 | Install Tagger Electrnc's (Installtn) |  | 10d | 2014-01-07 | 2014-01-21 | 9-140M FS+60d | 128d | 61d | 8/5 M-F w/JLAB Holidays ReBaseline | ELEC ENG [8 h]; ELEC TECH [240 h]; PLABOR | 16,862 | 2562090 | CHUDAKOV | 1 | 1 | D | S | EUGENE C | 13-007 |  | 13-015 | PR | 14-001 | PE | 07-024 | 09-014 | 11-006 | 11-026 |  | 12-054 |  |  | EJ |  | 11-044 |  |  |  |  |  |  |  |  |  |  |
| 2562505 | Install Trigger Electrnc's (Installtn) |  | 20d | 2014-01-07 | 2014-02-04 | 2543115 FS+16d, 282443020a, 282443020 | 128d | 109d | 8/5 M-F w/JLAB Holidays ReBaseline | ELEC TECH [200 h] | 9,398 | 2562505 | CHUDAKOV | 1 | 1 | D | U | EUGENE C |  |  | 13-015 | PR | 14-001 | EJ |  |  | 11-006 | 11-026 | 12-021 |  |  |  |  |  |  |  |  |  |  |  |  |  |  |  |  |
| 2562635 | Install air lines in hall D |  | 45d | 2014-01-07 | 2014-03-11 | 9-140M FS+60d | 142d |  | 8/5 M-F w/JLAB Holidays ReBaseline | MECH TECH [289.2 h]; MECH ENG [4 h] | 13,983.62 | 2562635 | CHUDAKOV | 1 | 1 | D | S | EUGENE C |  |  | 13-015 | PR | 14-001 | PE |  |  | 11-006 | 11-026 | 12-021 |  |  |  |  |  |  |  |  | 1 |  |  |  |  |  |  |  |
| 2562860 | Install Electron beamline to dump |  | 31d | 2014-01-08 | 2014-02-20 | 9-140M FS+61d | 155d |  | 8/5 M-F w/JLAB Holidays ReBaseline | MECH TECH [144 h]; SUPPLIES & MATERIALS; MECH ENG [8 h]; MECH DES [4 h] | 7,823.02 | 2562860 | CHUDAKOV | 1 | 1 | D | S | EUGENE C | 13-007 |  | 13-015 | PR | 14-001 | PE |  |  |  |  |  |  |  |  | EJ |  |  |  |  |  |  |  |  |  |  |  |  |
| 2562065 | Install Pwr for Tagger Electrnc's (Installtn) |  | 20d | 2014-01-09 | 2014-02-06 | 2562085, 9-140M FS+62d, 2562085a | 116d | 49d | 8/5 M-F w/JLAB Holidays ReBaseline | MECH TECH [136 h]; ELEC TECH [4 h]; ELEC ENG [8 h] | 7,224.52 | 2562065 | CHUDAKOV | 1 | 1 | D | S | EUGENE C |  |  | 13-015 | PR | 14-001 | PE |  | 09-014 | 11-006 | 11-026 | 12-021 | 12-054 |  |  |  |  | 11-044 | APP |  |  |  |  |  |  |  |  |  |
| 2562280 | Technical Support for Bcal Testing (Installtn) |  | 73d | 2014-01-10 | 2014-04-23 | 2562210 FS-14d, 25221060a FS-16d, 2562270 FS-43d, 2562275, 25221060 FS-16d, 2562275d | 17d | 0d | 8/5 M-F w/JLAB Holidays ReBaseline | ELEC ENG [80 h]; ELEC TECH [160 h] | 13,528.8 | 2562280 | CHUDAKOV | 1 | 1 | D | S | EUGENE C | 13-007 |  | 13-015 | PR | 14-001 | PE | 07-024 | 09-014 | 11-006 | 11-026 | 12-021 | 12-054 |  | 10-042 |  |  |  |  |  | 1 |  |  |  |  |  |  |  |
| 2562290b | Cables - Route on Racks CDC |  | 7d | 2014-01-13 | 2014-01-22 | 2562290a FS-3d | 134d | 0d | 8/5 M-F w/JLAB Holidays ReBaseline | ELEC TECH [80 h] | 3,759.2 | 2562290b | CHUDAKOV | 1 | 1 | D | U | EUGENE C | 13-007 |  | 13-015 | PR | 14-001 | PE | 07-024 | 09-014 | 11-006 | 11-026 | 12-021 | 12-054 |  |  |  |  |  |  |  |  |  |  |  |  |  |  |  |
| 2562380 | Insertion of FDC (Installtn) |  | 7d | 2014-01-13 | 2014-01-22 | 282462005 | 0d |  | 8/5 M-F w/JLAB Holidays ReBaseline | ELEC ENG [8 h]; PROCUREMENT<$50K 60; MECH TECH [160 h]; ELEC TECH [80 h]; MECH ENG [80 h] | 30,363.47 | 2562380 | CHUDAKOV | 1 | 1 | D | S | EUGENE C | 13-007 | EJ | 13-015 | PR | 14-001 | EJ | 07-024 | 09-014 | 11-006 | 11-026 | 12-021 | 12-054 |  | 10-042 |  |  |  | APP |  |  |  |  |  |  |  |  |  |
| 2562281 | Analyze BCAL Performance inside solenoid |  | 118d | 2014-01-15 | 2014-07-01 | 2562278 | 63d |  | 8/5 M-F w/JLAB Holidays ReBaseline | SCIENTIST [320 h] | 24,057.6 | 2562281 | CHUDAKOV | 1 | 1 | D | S | EUGENE C | 13-007 |  | 13-015 | PR | 14-001 | PE | 07-024 | 09-014 | 11-006 | 11-026 | 12-021 | 12-054 |  | 10-042 |  |  |  |  |  | 1 |  |  |  |  |  |  |  |
| 2562540 | Crates - Loaded (VME64x VXS HV LV) Install Hall BCAL |  | 10d | 2014-01-16 | 2014-01-30 | 2562535 FS-25d, 2548025a FS-25d, 2548025 FS-25d | 80d | 0d | 8/5 M-F w/JLAB Holidays ReBaseline | ELEC TECH [320 h] | 15,036.8 | 2562540 | CHUDAKOV | 1 | 1 | D | U | EUGENE C |  |  | 13-015 | PR | 14-001 | PE |  |  | 11-006 | 11-026 | 12-021 | 12-054 |  |  |  |  |  |  |  | 1 |  |  |  |  |  |  |  |
| 2562099b | Cables - Route on Racks Pair Spectrometer |  | 5d | 2014-01-21 | 2014-01-27 | 2562099a | 150d | 0d | 8/5 M-F w/JLAB Holidays ReBaseline | ELEC TECH [40 h] | 1,879.6 | 2562099b | CHUDAKOV | 1 | 1 | D | U | EUGENE C | 13-007 |  | 13-015 | PR | 14-001 | PE | 07-024 | 09-014 | 11-006 | 11-026 | 12-021 |  |  |  |  |  |  |  |  |  |  |  |  |  |  |  |  |
| 2562290c | Cables - Connect to Crate Electronics CDC |  | 6d | 2014-01-21 | 2014-01-28 | 2562250b, 2562250a, 2562250, 2562290b FS-2d | 134d | 10d | 8/5 M-F w/JLAB Holidays ReBaseline | ELEC ENG [40 h]; ELEC TECH [80 h] | 6,764.4 | 2562290c | CHUDAKOV | 1 | 1 | D | U | EUGENE C | 13-007 |  | 13-015 | PR | 14-001 | PE | 07-024 | 09-014 | 11-006 | 11-026 | 12-021 | 12-054 |  |  |  |  |  |  |  |  |  |  |  |  |  |  |  |
| 2562300 | Mounting CDC on cart align and insert into solenoid (Installtn) |  | 13d | 2014-01-23 | 2014-02-10 | 2562380, 2561110 | 34d | 0d | 8/5 M-F w/JLAB Holidays ReBaseline | MECH ENG [80 h]; MECH TECH [160 h]; SCIENTIST [40 h] | 16,552 | 2562300 | CHUDAKOV | 1 | 1 | D | S | EUGENE C | 13-007 |  | 13-015 | PR | 14-001 | PE | 07-024 | 09-014 | 11-006 | 11-026 | 12-021 | 12-054 |  | 10-042 |  |  |  |  |  | 1 |  |  |  |  |  |  |  |
| 2562385 | Cooling Sys Checks for FDC (Installtn) |  | 8d | 2014-01-23 | 2014-02-03 | 2562380 | 0d |  | 8/5 M-F w/JLAB Holidays ReBaseline | MECH ENG [16 h]; MECH TECH [80 h] | 4,980.32 | 2562385 | CHUDAKOV | 1 | 1 | D | H | EUGENE C | 13-007 |  | 13-015 | PR | 14-001 | EJ | 07-024 | 09-014 | 11-006 | 11-026 | 12-021 | 12-054 |  | 10-042 |  |  |  |  |  |  |  |  |  |  |  |  |  |
| 2562099c | Cables - Connect to Crate Electronics Pair Spectrometer |  | 10d | 2014-01-28 | 2014-02-10 | 2562099b | 150d | 2d | 8/5 M-F w/JLAB Holidays ReBaseline | ELEC TECH [40 h]; ELEC ENG [40 h] | 4,884.8 | 2562099c | CHUDAKOV | 1 | 1 | D | U | EUGENE C | 13-007 |  | 13-015 | PR | 14-001 | PE | 07-024 | 09-014 | 11-006 | 11-026 | 12-021 |  |  |  |  |  |  |  |  |  |  |  |  |  |  |  |  |
| 2562165 | Install High Granularity Pair Spectrometer (Installtn) |  | 35d | 2014-01-29 | 2014-03-18 | 2553135 FS-19d, 2546470 FS-20d, 2553125, 2546470a FS-20d, 2553044 | 137d |  | 8/5 M-F w/JLAB Holidays ReBaseline | MECH TECH [160 h]; MECH ENG [24 h]; SUPPLIES & MATERIALS; SCIENTIST [40 h] | 12,680.05 | 2562165 | CHUDAKOV | 1 | 1 | D | S | EUGENE C | 13-007 |  | 13-015 | PR | 14-001 | EJ | 07-024 | 09-014 | 11-006 | 11-026 | 12-021 | 12-054 |  |  | EJ |  |  | APP |  |  |  |  |  |  |  |  |  |
| 2562235 | Comp B-cal Assy (Installtn) |  | 10d | 2014-01-30 | 2014-02-12 | 25221057b, 2562830, 25221057ba, 25221057c, 2562233, 2562225, 2562245 FS+42d, 2562230a, 2562830a, 2562230, 25221057ca | 161d |  | 8/5 M-F w/JLAB Holidays ReBaseline | MECH TECH [152 h]; MECH ENG [32 h]; PROCUREMENT<$50K 60 | 12,073.78 | 2562235 | CHUDAKOV | 1 | 1 | D | S | EUGENE C | 13-007 | EJ | 13-015 | PR | 14-001 | EJ | 07-024 | 09-014 | 11-006 | 11-026 | 12-021 | 12-054 |  | 10-042 |  |  |  | APP |  | 1 |  |  | 11-040 | 11-054 |  |  |  |
| 2562545 | Crates - Loaded (VME64x VXS HV LV) Install Hall TOF |  | 5d | 2014-01-31 | 2014-02-06 | 2548025, 2562540, 2548025a | 145d | 81d | 8/5 M-F w/JLAB Holidays ReBaseline | ELEC TECH [80 h] | 3,759.2 | 2562545 | CHUDAKOV | 1 | 1 | D | U | EUGENE C |  |  | 13-015 | PR | 14-001 | PE |  |  | 11-006 | 11-026 | 12-021 | 12-054 |  |  |  |  |  |  |  | 1 |  |  |  |  |  |  |  |
| 2562420 | Install Supprt Electrnc's FCAL/TOF Racks (Installtn) |  | 41d | 2014-02-03 | 2014-03-31 | 9-140M FS+78d | 128d |  | 8/5 M-F w/JLAB Holidays ReBaseline | PLABOR; ELEC TECH [240 h] | 23,736.03 | 2562420 | CHUDAKOV | 1 | 1 | D | S | EUGENE C |  |  | 13-015 | PR | 14-001 | EJ | 07-024 |  | 11-006 | 11-026 | 12-021 | 12-054 |  |  | EJ | 07-027 |  |  |  |  |  |  |  |  | 09-045 | 11-049 |  |
| 2562303 | Install FDC/CDC Alignment Check System (Installtn) |  | 10d | 2014-02-10 | 2014-02-21 | 2562300 FS-1d | 51d | 34d | 8/5 M-F w/JLAB Holidays ReBaseline | MECH ENG [40 h]; MECH TECH [160 h] | 10,558 | 2562303 | CHUDAKOV | 1 | 1 | D | S | EUGENE C | 13-007 |  | 13-015 | PR | 14-001 | EJ | 07-024 | 09-014 | 11-006 | 11-026 | 12-021 | 12-054 |  | 10-042 |  |  |  |  |  | 1 |  |  |  |  |  |  |  |
| 2562301 | CDC mounting electronics and other connections in situ (Installtn) |  | 15d | 2014-02-11 | 2014-03-03 | 2562300 | 34d | 17d | 8/5 M-F w/JLAB Holidays ReBaseline | MECH TECH [40 h]; MECH ENG [40 h]; SCIENTIST [80 h]; ELEC TECH [80 h] | 14,653.2 | 2562301 | CHUDAKOV | 1 | 1 | D | U | EUGENE C | 13-007 |  | 13-015 | PR | 14-001 | EJ | 07-024 | 09-014 | 11-006 | 11-026 | 12-021 | 12-054 |  | 10-042 |  |  |  |  |  | 1 |  |  |  |  |  |  |  |
| 2562520 | Crates - Loaded (VME64x VXS HV LV) Install Hall Pair Spectrometer |  | 5d | 2014-02-11 | 2014-02-17 | 2548025a FS+32d, 2548025 FS+32d | 146d | 0d | 8/5 M-F w/JLAB Holidays ReBaseline | ELEC TECH [80 h] | 3,759.2 | 2562520 | CHUDAKOV | 1 | 1 | D | U | EUGENE C |  |  | 13-015 | PR | 14-001 | PE |  |  | 11-006 | 11-026 | 12-021 | 12-054 |  |  |  |  |  |  |  | 1 |  |  |  |  |  |  |  |
| 2562525 | Crates - Loaded (VME64x VXS HV LV) Install Hal Start Counter |  | 5d | 2014-02-18 | 2014-02-24 | 2548025, 2548025a, 2562520 | 146d | 105d | 8/5 M-F w/JLAB Holidays ReBaseline | ELEC TECH [80 h] | 3,759.2 | 2562525 | CHUDAKOV | 1 | 1 | D | U | EUGENE C |  |  | 13-015 | PR | 14-001 | PE |  |  | 11-006 | 11-026 | 12-021 | 12-054 |  |  |  |  |  |  |  | 1 |  |  |  |  |  |  |  |
| 2562780 | Install Commissioning target with Start Counter |  | 21d | 2014-03-03 | 2014-03-31 | 2562775 FS+5d | 128d |  | 8/5 M-F w/JLAB Holidays ReBaseline | MECH TECH [120 h]; SCIENTIST [48 h]; MECH ENG [12 h] | 10,183.08 | 2562780 | CHUDAKOV | 1 | 1 | D | H | EUGENE C | 13-007 |  | 13-015 | PR | 14-001 | EJ |  |  |  |  |  |  |  |  |  |  |  |  |  |  |  |  |  |  |  |  |  |
| 2562885 | Install flammable gas detection system |  | 45d | 2014-03-10 | 2014-05-09 | 2562880 FS+25d | 99d |  | 8/5 M-F w/JLAB Holidays ReBaseline | MECH TECH [112 h]; MECH ENG [84 h]; MECH DES [4 h] | 11,777.32 | 2562885 | CHUDAKOV | 1 | 1 | D | S | EUGENE C | 13-007 |  | 13-015 | PR | 14-001 | EJ |  |  |  |  |  |  |  |  |  |  |  |  |  |  |  |  |  |  |  |  |  |
| 2562170 | Install Photon Beam Profiler (Installtn) |  | 24d | 2014-03-26 | 2014-04-28 | 2553055 FS+5d | 108d |  | 8/5 M-F w/JLAB Holidays ReBaseline | MECH TECH [96 h]; PLABOR; SUPPLIES & MATERIALS; SCIENTIST [80 h]; MECH ENG [20 h]; MECH DES [8 h] | 12,564.11 | 2562170 | CHUDAKOV | 1 | 1 | D | S | EUGENE C | 13-007 |  | 13-015 | PR | 14-001 | PE | 07-024 |  | 11-006 | 11-026 | 12-021 | 12-054 |  |  | EJ |  |  |  |  |  |  |  |  |  |  |  | 11-004 |
| 2562080 | Install Hodoscope (Installtn) |  | 10d | 2014-04-02 | 2014-04-15 | 2546585, 2546605a, 2546605b, 2546600, 2562440 FS-200d, 2562061, 25512070, 2546585b, 25512005a, 25512010aa, 25512010, 25512010a, 2546605, 2546585a, 25512060, 25512176, 25512013LOE | 67d | 0d | 8/5 M-F w/JLAB Holidays ReBaseline | SUPPLIES & MATERIALS; SCIENTIST [72 h]; MECH ENG [52 h]; MECH TECH [344 h]; PLABOR | 28,979.15 | 2562080 | CHUDAKOV | 1 | 1 | D | S | EUGENE C | 13-007 |  | 13-015 | PR | 14-001 | EJ | 07-024 |  | 11-006 | 11-026 | 12-021 |  |  |  | EJ |  |  |  |  |  |  |  |  |  |  |  |  |
| 2562450 | Install TOF Sys (Installtn) |  | 17d | 2014-04-08 | 2014-04-30 | 2561165 FS-14d, 2562480a, 2562480 | 64d | 0d | 8/5 M-F w/JLAB Holidays ReBaseline | MECH TECH [220 h]; MECH ENG [16 h]; MECH DES [8 h]; SUPPLIES & MATERIALS | 13,253.8 | 2562450 | CHUDAKOV | 1 | 1 | D | S | EUGENE C | 13-007 |  | 13-015 | PR | 14-001 | EJ | 07-024 | 09-014 | 11-006 | 11-026 |  | 12-054 |  |  | EJ |  |  | APP |  |  |  | 12-049 |  |  |  |  |  |
| 2562630 | Install nitrogen lines in hall D |  | 26d | 2014-04-11 | 2014-05-16 | 2562810 FS+63d | 94d |  | 8/5 M-F w/JLAB Holidays ReBaseline | MECH TECH [289.2 h] | 13,684.94 | 2562630 | CHUDAKOV | 1 | 1 | D | S | EUGENE C | 13-007 |  | 13-015 | PR | 14-001 | PE |  |  | 11-006 | 11-026 | 12-021 |  |  |  |  |  |  |  |  | 1 |  |  |  |  |  |  |  |
| 2562095 | Cables - Install on Trays Detector to Racks Tagger |  | 10d | 2014-04-17 | 2014-04-30 | 2562085, 2562080 FS+1d, 2562090, 2562085a, 2562065 | 67d | 0d | 8/5 M-F w/JLAB Holidays ReBaseline | SCIENTIST; ELEC TECH [80 h] | 3,759.2 | 2562095 | CHUDAKOV | 1 | 1 | D | U | EUGENE C | 13-007 |  | 13-015 | PR | 14-001 | PE | 07-024 | 09-014 | 11-006 | 11-026 | 12-021 |  |  |  |  |  |  |  |  |  |  |  |  |  |  |  |  |
| 2562515 | Crates - Loaded (VME64x VXS HV LV) Install Hall Tagger |  | 5d | 2014-04-22 | 2014-04-28 | 2548025a, 9-140M FS+134d, 2548025 | 98d | 31d | 8/5 M-F w/JLAB Holidays ReBaseline | ELEC TECH [80 h] | 3,759.2 | 2562515 | CHUDAKOV | 1 | 1 | D | U | EUGENE C |  |  | 13-015 | PR | 14-001 | PE | 07-024 | 09-014 | 11-006 | 11-026 | 12-021 | 12-054 |  | 10-042 |  |  |  |  |  | 1 |  |  |  |  |  |  |  |
| 2562455 | Cables - Install on Trays Detector to Racks TOF |  | 5d | 2014-05-01 | 2014-05-07 | 2547190a, 2547200a, 2547200, 2547190, 2562450, 2562035M | 64d | 0d | 8/5 M-F w/JLAB Holidays ReBaseline | SCIENTIST; ELEC TECH [160 h] | 7,518.4 | 2562455 | CHUDAKOV | 1 | 1 | D | U | EUGENE C | 13-007 |  | 13-015 | PR | 14-001 | PE | 07-024 | 09-014 | 11-006 | 11-026 |  | 12-054 |  |  |  |  |  |  |  |  |  | 12-049 |  |  |  |  |  |
| 2562900 | Preparing OSP ESAD documentation Rediness Review for October 14 Beam Run |  | 93d | 2014-05-06 | 2014-09-16 | 2562890 FS-104d | 10d |  | 8/5 M-F w/JLAB Holidays ReBaseline | MECH TECH [40 h]; MECH ENG [240 h]; SR STAFF [400 h]; SCIENTIST [360 h]; MECH DES [120 h]; ELEC ENG [40 h]; SUPPLIES & MATERIALS | 106,747.35 | 2562900 | CHUDAKOV | 1 | 1 | D | S | EUGENE C | 13-007 |  | 13-015 | PR | 14-001 | PE |  |  |  |  |  |  |  |  | PE |  |  |  |  |  |  |  |  |  |  |  |  |

| ID | WBS | Activity | Type | Duration | Start | Finish | Predecessors | Total float | Free float | Calendar | Resources | Cost | Original Activity ID Rebaseline | RESP - Responsibility | STRT%COMP for CM EVM | FNSH%COMP for CM EVM | HALL D Related Milestones | CR 07-024 | EVMS Reporting Codes | CAM RESPONSIBLE | CR 09-014 | CR 11-006 | CR 11-026 | CR 12-021 | CR 13-007 | BOE Labor | CR 13-015 | Post Rebaseline | CR 14-001 | CR 12-049 | CR 12-054 | 12 GeV 1st level Critical Path | CR 10-042 | CR 09-027 | CR 09-027 Repair | Advance Purchase Plan > 500K | BOE Expenses | CR 11-004 | CR 11-036 | CR 10-024 | CR 11-001 | CR 13-014 | ReBaseline Actuals Adjustment |
| --- | --- | --- | --- | --- | --- | --- | --- | --- | --- | --- | --- | --- | --- | --- | --- | --- | --- | --- | --- | --- | --- | --- | --- | --- | --- | --- | --- | --- | --- | --- | --- | --- | --- | --- | --- | --- | --- | --- | --- | --- | --- | --- | --- |
| 2562095a |  | Cables - Route and Connect on Detector Tagger |  | 10d | 2014-05-07 | 2014-05-20 | 2562095 FS+4d | 67d | 0d | 8/5 M-F w/JLAB Holidays ReBaseline | SCIENTIST; ELEC TECH [80 h] | 3,759.2 | 2562095a | CHUDAKOV | 1 | 1 | D | 07-024 | U | EUGENE C | 09-014 | 11-006 | 11-026 | 12-021 | 13-007 | PE | 13-015 | PR | 14-001 |  |  |  |  |  |  |  |  |  |  |  |  |  |  |
| 2562460 |  | Test TOF Sys (Installtn) |  | 20d | 2014-05-08 | 2014-06-05 | 2562455 | 81d |  | 8/5 M-F w/JLAB Holidays ReBaseline | ELEC ENG [80 h]; ELEC TECH [320 h] | 21,047.2 | 2562460 | CHUDAKOV | 1 | 1 | D | 07-024 | U | EUGENE C | 09-014 | 11-006 | 11-026 |  | 13-007 | EJ | 13-015 | PR | 14-001 | 12-049 | 12-054 |  |  |  |  |  |  |  |  |  |  |  |  |
| 2562455a |  | Cables - Route and Connect on Detector TOF |  | 5d | 2014-05-15 | 2014-05-21 | 2562455 FS+5d | 64d | 0d | 8/5 M-F w/JLAB Holidays ReBaseline | SCIENTIST; ELEC TECH [160 h] | 7,518.4 | 2562455a | CHUDAKOV | 1 | 1 | D | 07-024 | U | EUGENE C | 09-014 | 11-006 | 11-026 |  | 13-007 | PE | 13-015 | PR | 14-001 | 12-049 | 12-054 |  |  |  |  |  |  |  |  |  |  |  |  |
| 2562095b |  | Cables - Route on Racks Tagger |  | 5d | 2014-05-21 | 2014-05-28 | 2562095a | 67d | 0d | 8/5 M-F w/JLAB Holidays ReBaseline | ELEC TECH [40 h] | 1,879.6 | 2562095b | CHUDAKOV | 1 | 1 | D | 07-024 | U | EUGENE C | 09-014 | 11-006 | 11-026 | 12-021 | 13-007 | PE | 13-015 | PR | 14-001 |  |  |  |  |  |  |  |  |  |  |  |  |  |  |
| 2562455b |  | Cables - Route on Racks TOF |  | 5d | 2014-05-22 | 2014-05-29 | 2562455a | 64d | 0d | 8/5 M-F w/JLAB Holidays ReBaseline | SCIENTIST; ELEC TECH [80 h] | 3,759.2 | 2562455b | CHUDAKOV | 1 | 1 | D | 07-024 | U | EUGENE C | 09-014 | 11-006 | 11-026 |  | 13-007 | PE | 13-015 | PR | 14-001 | 12-049 | 12-054 |  |  |  |  |  |  |  |  |  |  |  |  |
| 2562095c |  | Cables - Connect to Crate Electronics Tagger |  | 10d | 2014-05-29 | 2014-06-11 | 2562095b | 67d | 0d | 8/5 M-F w/JLAB Holidays ReBaseline | ELEC ENG [40 h]; ELEC TECH [40 h] | 4,884.8 | 2562095c | CHUDAKOV | 1 | 1 | D | 07-024 | U | EUGENE C | 09-014 | 11-006 | 11-026 | 12-021 | 13-007 | PE | 13-015 | PR | 14-001 |  |  |  |  |  |  |  |  |  |  |  |  |  |  |
| 2562455c |  | Cables - Connect to Crate Electronics TOF |  | 2d | 2014-05-30 | 2014-06-02 | 2562455b | 64d | 0d | 8/5 M-F w/JLAB Holidays ReBaseline | ELEC ENG [40 h]; ELEC TECH [40 h] | 4,884.8 | 2562455c | CHUDAKOV | 1 | 1 | D | 07-024 | U | EUGENE C | 09-014 | 11-006 | 11-026 |  | 13-007 | PE | 13-015 | PR | 14-001 | 12-049 | 12-054 |  |  |  |  |  |  |  |  |  |  |  |  |
| 2562510 |  | Check-out Trigger Electrnc's (Installtn) |  | 39d | 2014-07-10 | 2014-09-03 | 2562505, 2531125 FS-20d | 19d |  | 8/5 M-F w/JLAB Holidays ReBaseline | ELEC ENG [60 h]; ELEC TECH [60 h] | 7,327.2 | 2562510 | CHUDAKOV | 1 | 1 | D | 07-024 | U | EUGENE C |  | 11-006 | 11-026 | 12-021 |  | EJ | 13-015 | PR | 14-001 |  |  |  |  |  |  |  |  |  |  |  |  |  |  |
| 2562490 |  | Cables - Install on Trays Detector to Racks Start Counter |  | 2d | 2014-08-18 | 2014-08-19 | 2562485 FS-11d, 2562245 | 19d | 0d | 8/5 M-F w/JLAB Holidays ReBaseline | SCIENTIST; ELEC TECH [80 h] | 3,759.2 | 2562490 | CHUDAKOV | 1 | 1 | D | 07-024 | U | EUGENE C | 09-014 | 11-006 | 11-026 | 12-021 | 13-007 | PE | 13-015 | PR | 14-001 |  | 12-054 | 1 | 10-042 |  |  |  |  |  |  |  |  |  |  |
| 2562485 |  | Install Start Counter Onto LH Target (Installtn) |  | 10d | 2014-08-19 | 2014-09-02 | 25213005, 2552040, 2552007, 282462000, 2552006 | 11d | 0d | 8/5 M-F w/JLAB Holidays ReBaseline | MECH ENG [12 h]; MECH TECH [104 h]; SCIENTIST [160 h] | 17,846.12 | 2562485 | CHUDAKOV | 1 | 1 | D | 07-024 | S | EUGENE C | 09-014 | 11-006 | 11-026 | 12-021 | 13-007 | PE | 13-015 | PR | 14-001 |  | 12-054 | 1 | 10-042 | 09-027 | 09-027 |  |  |  |  |  |  |  |  |
| 2562490a |  | Cables - Route and Connect on Detector Start Counter |  | 2d | 2014-08-20 | 2014-08-21 | 2562490 | 41d | 0d | 8/5 M-F w/JLAB Holidays ReBaseline | SCIENTIST; ELEC TECH [80 h] | 3,759.2 | 2562490a | CHUDAKOV | 1 | 1 | D | 07-024 | U | EUGENE C | 09-014 | 11-006 | 11-026 | 12-021 | 13-007 | PE | 13-015 | PR | 14-001 |  | 12-054 |  |  |  |  |  |  |  |  |  |  |  |  |
| 2562495 |  | Test Start Counter (Installtn) |  | 10d | 2014-08-20 | 2014-09-03 | 2562490 | 19d |  | 8/5 M-F w/JLAB Holidays ReBaseline | ELEC ENG [8 h]; ELEC TECH [200 h] | 9,999.04 | 2562495 | CHUDAKOV | 1 | 1 | D | 07-024 | H | EUGENE C | 09-014 | 11-006 | 11-026 | 12-021 | 13-007 | EJ | 13-015 | PR | 14-001 |  | 12-054 | 1 | 10-042 |  |  |  |  |  |  |  |  |  |  |
| 2562490b |  | Cables - Route on Racks Start Counter |  | 2d | 2014-08-22 | 2014-08-25 | 2562490a | 41d | 0d | 8/5 M-F w/JLAB Holidays ReBaseline | ELEC TECH [40 h] | 1,879.6 | 2562490b | CHUDAKOV | 1 | 1 | D | 07-024 | U | EUGENE C | 09-014 | 11-006 | 11-026 | 12-021 | 13-007 | PE | 13-015 | PR | 14-001 |  | 12-054 |  |  |  |  |  |  |  |  |  |  |  |  |
| 2562490c |  | Cables - Connect to Crate Electronics Start Counter |  | 2d | 2014-08-26 | 2014-08-27 | 2562490b | 41d | 0d | 8/5 M-F w/JLAB Holidays ReBaseline | ELEC ENG [40 h]; ELEC TECH [40 h] | 4,884.8 | 2562490c | CHUDAKOV | 1 | 1 | D | 07-024 | U | EUGENE C | 09-014 | 11-006 | 11-026 | 12-021 | 13-007 | PE | 13-015 | PR | 14-001 |  | 12-054 |  |  |  |  |  |  |  |  |  |  |  |  |
| 2562175 |  | Install Hydrogen Target and Start Counter Inside Detector (Installtn) |  | 10d | 2014-09-02 | 2014-09-15 | 282446035, 25213025, 2552040, 2546567a, 282446030, 2546567, 282446040a, 282446040, 2562485 FS-1d, 282446030a, 282446035a | 11d |  | 8/5 M-F w/JLAB Holidays ReBaseline | SUPPLIES & MATERIALS; MECH TECH [576 h]; MECH ENG [12 h] | 34,343.76 | 2562175 | CHUDAKOV | 1 | 1 | D | 07-024 | S | EUGENE C | 09-014 | 11-006 | 11-026 | 12-021 | 13-007 | PE | 13-015 | PR | 14-001 |  | 12-054 |  | 10-042 | 09-027 | 09-027 | APP | EJ |  |  |  |  |  |  |
| 2562091M |  | Tagger Ready For Beam (Installtn) | milestone | 0d | 2014-09-04 | 2014-09-04 | 282453000, 2562061, 2553195, 2562098, 2562060 | 18d |  | 8/5 M-F w/JLAB Holidays ReBaseline |  |  | 2562091M | CHUDAKOV | 1 | 1 | D | 07-024 | M | EUGENE C | 09-014 | 11-006 | 11-026 | 12-021 | 13-007 |  | 13-015 | PR |  |  |  |  |  |  |  |  |  |  |  |  |  |  |  |
|  | 3 | **1.5.6.3 CRYOGENICS** |  |  | 2010-01-05 | 2013-08-30 |  |  |  |  |  |  |  |  |  |  |  |  |  |  |  |  |  |  |  |  |  |  |  |  |  |  |  |  |  |  |  |  |  |  |  |  |  |
| 1563005 |  | Release U-tube Fabrication Drawings (CRYOGENICS) |  | 130d | 2010-01-05 | 2010-07-09 | 9-100M FS+60d | 443d | 0d |  | MECH ENG [40 h]; MECH TECH [40 h] | 4,303.6 |  | CHUDAKOV | 1 | 1 | D | 07-024 |  | EUGENE C |  | 11-006 |  |  |  |  |  |  |  |  |  |  | 10-042 |  |  |  |  | 11-004 | 11-036 |  |  |  |  |
| 1563010 |  | Release Warm Gas Plumbing Fabrication Drawings (CRYOGENICS) (Frozen per CR11-036) |  | 130d | 2010-01-05 | 2010-07-09 | 9-100M FS+60d | 454d | 0d |  | MECH TECH [320 h]; MECH ENG [40 h]; MECH DES [80 h] | 19,610 |  | CHUDAKOV | 1 | 1 | D | 07-024 |  | EUGENE C |  | 11-006 |  |  |  |  |  |  |  |  |  |  | 10-042 |  |  |  |  | 11-004 | 11-036 |  |  |  |  |
| 1563015 |  | Release Transfer Line Fabrication Drawings (CRYOGENICS) (Frozen per CR11-036) |  | 130d | 2010-01-05 | 2010-07-09 | 9-100M FS+60d | 408d | 0d |  | MECH DES [360 h]; MECH ENG [40 h]; MECH TECH [160 h] | 25,598.8 |  | CHUDAKOV | 1 | 1 | D | 07-024 |  | EUGENE C |  | 11-006 |  |  |  |  |  |  |  |  |  |  | 10-042 |  |  |  |  | 11-004 | 11-036 |  |  |  |  |
| 1563020 |  | Release Cryogenic Instrumentation Drawings (CRYOGENICS) (Frozen per CR11-036) |  | 130d | 2010-01-05 | 2010-07-09 | 9-100M FS+60d | 437d | 0d |  | MECH ENG [80 h]; MECH TECH [320 h]; MECH DES [120 h] | 24,053.6 |  | CHUDAKOV | 1 | 1 | D | 07-024 |  | EUGENE C |  | 11-006 |  |  |  |  |  |  |  |  |  |  | 10-042 |  |  |  |  | 11-004 | 11-036 |  |  |  |  |
| 1563016 |  | Proc Transfer Line (CRYOGENICS) (Frozen per CR11-036) |  | 141d | 2010-06-04 | 2010-12-30 | 1563015 FS-25d | 437d |  |  | PROCUREMENT>$50K 69 NO ESCALATION FY11 | 68,124.69 |  | CHUDAKOV | 1 | 1 | D |  |  | EUGENE C |  | 11-006 |  |  |  |  |  |  |  |  |  |  | 10-042 |  |  |  |  | 11-004 | 11-036 |  |  |  |  |
| 1563011 |  | Proc Warm Gas Plumbing (CRYOGENICS) (Frozen per CR11-036) |  | 116d | 2010-06-16 | 2010-11-30 | 1563010 FS-17d | 454d |  |  | PROCUREMENT>$50K 69 NO ESCALATION FY11 | 17,580.56 |  | CHUDAKOV | 1 | 1 | D |  |  | EUGENE C |  | 11-006 |  |  |  |  |  |  |  |  |  |  | 10-042 |  |  |  |  | 11-004 | 11-036 |  |  |  |  |
| 1563006 |  | Proc U-tubes (CRYOGENICS) (Frozen per CR11-036) |  | 116d | 2010-07-01 | 2010-12-15 | 1563005 FS-6d | 443d |  |  | PROCUREMENT>$50K 69 NO ESCALATION FY11 | 17,580.56 |  | CHUDAKOV | 1 | 1 | D |  |  | EUGENE C |  | 11-006 |  |  |  |  |  |  |  |  |  |  | 10-042 |  |  |  |  | 11-004 | 11-036 |  |  |  |  |
| 1563017 |  | Proc Cryo Distribution for Magnet (Labor) (CRYOGENICS) FY10 (Frozen per CR11-036) |  | 58d | 2010-07-12 | 2010-09-30 | 1563015 | 408d | 0d |  | MECH ENG [160 h] | 10,536 |  | CHUDAKOV | 1 | 1 | D |  |  | EUGENE C |  | 11-006 |  |  |  |  |  |  |  |  |  |  |  |  |  |  |  | 11-004 | 11-036 | 10-024 | 11-001 |  |  |
| 1563025 |  | Proc Cryogenic Instrumentation (CRYOGENICS) (Frozen per CR11-036) |  | 101d | 2010-08-02 | 2010-12-30 | 1563020 FS+15d | 437d |  |  | PROCUREMENT<$50K 60 NO ESCALATION FY11 | 5,493.93 |  | CHUDAKOV | 1 | 1 | D | 07-024 |  | EUGENE C |  | 11-006 |  |  |  |  |  |  |  |  |  |  | 10-042 |  |  |  |  | 11-004 | 11-036 |  |  |  |  |
| 1563017a |  | Proc Cryo Distribution for Magnet (Labor) (CRYOGENICS) FY11 (Frozen per CR11-036) |  | 87d | 2010-10-01 | 2011-02-11 | 1563017 | 408d |  |  | MECH ENG [240 h] | 16,308 |  | CHUDAKOV | 1 | 1 | D |  |  | EUGENE C |  | 11-006 |  |  |  |  |  |  |  |  |  |  |  |  |  |  |  | 11-004 | 11-036 | 10-024 | 11-001 |  |  |
| 1563030 |  | Reverse Entry per CR11-036 |  | 5d | 2011-08-01 | 2011-08-05 | 9-110M FS+204d | 39d |  |  | MECH ENG [-540 h]; MECH TECH [-580 h]; PROCUREMENT<$50K 60; PROCUREMENT>$50K 69; MECH DES [-340 h] | -186,324.54 |  | CHUDAKOV | 1 | 1 | D | 07-024 |  | EUGENE C |  | 11-006 |  |  |  |  |  |  |  |  |  |  | 10-042 |  |  |  |  | 11-004 | 11-036 |  |  |  |  |
| 1563035 |  | Re-Baseline Actuals Adjustment |  | 1d | 2013-08-30 | 2013-08-30 | 9-130M FS+227d | 20d |  |  | PROCUREMENT>$50K 69 NO ESCALATION | 128,274.73 |  | CHUDAKOV | 1 | 1 |  |  |  | EUGENE C |  |  |  |  |  |  |  |  |  |  |  |  |  |  |  |  |  |  |  |  |  | 13-014 | ADJ |

Notes:
- 2562175: Explanation: IPL from 6 GeV 551210

| ID | WBS | Activity | Type | Duration | Start | Finish | Predecessors | Total float | Free float | Resources | Cost | RESP - Responsibility | STRT%COMP for CM EVM | FNSH%COMP for CM EVM | HALL D Related Milestones | CAM RESPONSIBLE | CR 11-037 | CR 12-021 | CR 13-014 | ReBaseline Actuals Adjustment | Milestone Level | CR 10-028 | CR 11-055 | CR 12-029 | Advance Purchase Plan > 500K | CR 08-014 | CR 08-016 | 12 GEV MAJOR PROCUREMENT CATAGORY | CR 09-012 | CR 10-032 | CR 10-045 | CR 07-029 | CR 11-001 |
| --- | --- | --- | --- | --- | --- | --- | --- | --- | --- | --- | --- | --- | --- | --- | --- | --- | --- | --- | --- | --- | --- | --- | --- | --- | --- | --- | --- | --- | --- | --- | --- | --- | --- |
|  | 7 | **1.5.7 SPARE HALL D SOLENOID** |  |  | 2011-07-01 | 2013-08-30 |  |  |  |  |  |  |  |  |  |  |  |  |  |  |  |  |  |  |  |  |  |  |  |  |  |  |  |
| 157005 |  | Spare Hall D Solenoid Procurement Process FY11 Labor |  | 64d | 2011-07-01 | 2011-09-30 | 9-110M FS+184d | 373d | 0d | SR STAFF [256 h] | 28,034.56 | CHUDAKOV | 1 | 1 | D | EUGENE C | 11-037 | 12-021F |  |  |  |  |  |  |  |  |  |  |  |  |  |  |  |
| 157010 |  | Spare Hall D Solenoid Procurement Process FY12 Labor |  | 58d | 2011-10-03 | 2011-12-30 | 157005 | 373d | 0d | SR STAFF [232 h] | 26,216 | CHUDAKOV | 1 | 1 | D | EUGENE C | 11-037 | 12-021F |  |  |  |  |  |  |  |  |  |  |  |  |  |  |  |
| 157020 |  | Spare Hall D Solenoid FY12 Oversight Labor |  | 20d | 2012-01-03 | 2012-01-31 | 157010 | 373d | 353d | SR STAFF [80 h] | 9,040 | CHUDAKOV | 1 | 1 | D | EUGENE C | 11-037 | 12-021 |  |  |  |  |  |  |  |  |  |  |  |  |  |  |  |
| 157030 |  | Spare Hall D Solenoid FY13 Oversight Labor |  | 44d | 2013-07-01 | 2013-08-30 | 157020, 9-130M FS+184d | 20d |  | SR STAFF [464.75 h] | 54,189.85 | CHUDAKOV | 1 | 1 | D | EUGENE C | 11-037 | 12-021 | 13-014 |  |  |  |  |  |  |  |  |  |  |  |  |  |  |
| 157045 |  | Re-Baseline Actuals Adjustment |  | 1d | 2013-08-30 | 2013-08-30 | 9-130M FS+227d | 20d |  | PROCUREMENT>$50K 69 NO ESCALATION | -63,176.3 | CHUDAKOV | 1 | 1 |  | EUGENE C |  |  | 13-014 | ADJ |  |  |  |  |  |  |  |  |  |  |  |  |  |
|  | 6 | **1.6 CONVENTIONAL FACILITIES** |  |  | 2008-12-12 | 2015-10-02 |  |  |  |  |  |  |  |  |  |  |  |  |  |  |  |  |  |  |  |  |  |  |  |  |  |  |  |
|  | 1 | **1.6.1 ACCELERATOR** |  |  | 2009-10-01 | 2015-10-02 |  |  |  |  |  |  |  |  |  |  |  |  |  |  |  |  |  |  |  |  |  |  |  |  |  |  |  |
|  | 1 | **1.6.1.1 BUILDINGS** |  |  | 2009-10-01 | 2015-10-02 |  |  |  |  |  |  |  |  |  |  |  |  |  |  |  |  |  |  |  |  |  |  |  |  |  |  |  |
|  | 1 | **1.6.1.1.1 NORTH & SOUTH ACCESS BUILDING ADDITIONS** |  |  | 2009-10-01 | 2013-08-30 |  |  |  |  |  |  |  |  |  |  |  |  |  |  |  |  |  |  |  |  |  |  |  |  |  |  |  |
| 16111000M |  | N&S Access Addition Begin Constr | milestone | 0d | 2009-10-01 | 2009-10-01 | 9-100M, 1241035M | 162d | 0d |  |  | WHITLATCH C | 1 | 1 |  | REBECCA Y |  |  |  |  | 6 | 10-028 | 11-055 |  |  |  |  |  |  |  |  |  |  |
| 16111005 |  | N&S Access Addition Award Contract |  | 60d | 2009-10-01 | 2010-01-04 | 16111000M | 278d | 0d | PLANT ENG [80 h] | 5,277.6 | WHITLATCH C | 1 | 1 |  | REBECCA Y |  |  |  |  |  | 10-028 | 11-055 | 12-029F |  |  |  |  |  |  |  |  |  |
| 16111010 |  | N&S Access Constrctn Contract April Progress Payment |  | 72d | 2010-01-20 | 2010-04-30 | 16111005 FS+10d | 278d | 0d | PROCUREMENT<$50K 60 NO ESCALATION; PROCUREMENT>$50K 69 NO ESCALATION | 81,143 | WHITLATCH C | 1 | 1 |  | REBECCA Y |  |  |  |  |  | 10-028 | 11-055 | 12-029F | APP | 08-014 | 08-016 | 6111 | 09-012 | 10-032 | 10-045 |  |  |
| 16111010A |  | N&S Access Constrctn Contract May Progress Payment |  | 92d | 2010-01-20 | 2010-05-28 | 16111010 FS-72d | 278d | 0d | PROCUREMENT>$50K 69 NO ESCALATION | 190,355 | WHITLATCH C | 1 | 1 |  | REBECCA Y |  |  |  |  |  | 10-028 | 11-055 | 12-029F | APP |  |  | 6111 |  |  | 10-045 |  |  |
| 16111010B |  | N&S Access Constrctn Contract June Progress Payment |  | 114d | 2010-01-20 | 2010-06-30 | 16111010A FS-92d | 278d | 0d | PROCUREMENT>$50K 69 NO ESCALATION | 206,252 | WHITLATCH C | 1 | 1 |  | REBECCA Y |  |  |  |  |  | 10-028 | 11-055 | 12-029F | APP |  |  | 6111 |  |  | 10-045 |  |  |
| 16111010C |  | N&S Access Constrctn Contract July Progress Payment |  | 135d | 2010-01-20 | 2010-07-30 | 16111010B FS-114d | 278d | 0d | PROCUREMENT>$50K 69 NO ESCALATION | 565,312 | WHITLATCH C | 1 | 1 |  | REBECCA Y |  |  |  |  |  | 10-028 | 11-055 | 12-029F | APP |  |  | 6111 |  |  | 10-045 |  |  |
| 16111010D |  | N&S Access Constrctn Contract August Progress Payment |  | 157d | 2010-01-20 | 2010-08-31 | 16111010C FS-135d | 278d | 0d | PROCUREMENT>$50K 69 NO ESCALATION | 181,930 | WHITLATCH C | 1 | 1 |  | REBECCA Y |  |  |  |  |  | 10-028 | 11-055 | 12-029F | APP |  |  | 6111 |  |  | 10-045 |  |  |
| 16111010G |  | N&S Access Constrctn Contract September Progress Payment |  | 178d | 2010-01-20 | 2010-09-30 | 16111010D FS-157d | 278d | 0d | PROCUREMENT>$50K 69 NO ESCALATION | 110,544 | WHITLATCH C | 1 | 1 |  | REBECCA Y |  |  |  |  |  | 10-028 | 11-055 | 12-029F | APP |  |  | 6111 |  |  | 10-045 |  |  |
| 16111010H |  | N&S Access Constrctn Contract October Progress Payment |  | 199d | 2010-01-20 | 2010-10-29 | 16111010G FS-178d | 278d | 0d | PROCUREMENT>$50K 69 NO ESCALATION | 49,511 | WHITLATCH C | 1 | 1 |  | REBECCA Y |  |  |  |  |  | 10-028 | 11-055 | 12-029F | APP |  |  | 6111 |  |  | 10-045 |  |  |
| 16111010J |  | N&S Access Constrctn Contract November Progress Payment |  | 219d | 2010-01-20 | 2010-11-30 | 16111010H FS-199d | 278d | 0d | PROCUREMENT>$50K 69 NO ESCALATION | 14,655 | WHITLATCH C | 1 | 1 |  | REBECCA Y |  |  |  |  |  | 10-028 | 11-055 | 12-029F | APP |  |  | 6111 |  |  | 10-045 |  |  |
| 16111010K |  | N&S Access Constrctn Contract December Progress Payment |  | 236d | 2010-01-20 | 2010-12-30 | 16111010J FS-219d | 278d | 0d | PROCUREMENT>$50K 69 NO ESCALATION | 11,941 | WHITLATCH C | 1 | 1 |  | REBECCA Y |  |  |  |  |  | 10-028 | 11-055 | 12-029F | APP |  |  | 6111 |  |  | 10-045 |  |  |
| 16111010N |  | N&S Access Constrctn Contract January Progress Payment |  | 249d | 2010-01-20 | 2011-01-20 | 16111010K FS-236d | 278d | 0d | PROCUREMENT>$50K 69 NO ESCALATION | 367 | WHITLATCH C | 1 | 1 |  | REBECCA Y |  |  |  |  |  | 10-028 | 11-055 | 12-029F | APP |  |  | 6111 |  |  | 10-045 |  |  |
| 16111012 |  | N&S Access Constrctn Contract Modifications |  | 249d | 2010-01-20 | 2011-01-20 | 16111005 FS+10d | 278d | 0d | PROCUREMENT>$50K 69 NO ESCALATION | 70,600.5 | WHITLATCH C | 1 | 1 |  | REBECCA Y |  |  |  |  |  | 10-028 | 11-055 | 12-029F | APP |  |  | 6111 |  | 10-032 |  |  |  |
| 16111020 |  | N&S Access Addition Constrctn Mngmnt FY10 |  | 178d | 2010-01-20 | 2010-09-30 | 16111005 FS+10d | 278d | 0d | MECH DES [24.64 h]; PLANT ENG [813.01 h]; OFFICE [344.91 h]; ELEC ENG [49.27 h]; MECH ENG [24.64 h]; MECH TECH [862.28 h] | 104,875.25 | WHITLATCH C | 1 | 1 |  | REBECCA Y |  |  |  |  |  | 10-028 | 11-055 | 12-029F |  |  |  |  |  | 10-032 |  | 07-029 | 11-001 |
| 16111020a |  | N&S Access Addition Constrctn Mngmnt FY11 |  | 111d | 2010-10-01 | 2011-03-18 | 16111020, 16111005 FS+10d | 278d | 0d | MECH DES [15.36 h]; PLANT ENG [506.99 h]; OFFICE [215.09 h]; ELEC ENG [30.73 h]; MECH ENG [15.36 h]; MECH TECH [537.72 h] | 67,483.98 | WHITLATCH C | 1 | 1 |  | REBECCA Y |  |  |  |  |  | 10-028 | 11-055 | 12-029F |  |  |  |  |  | 10-032 |  | 07-029 | 11-001 |
| 16111015 |  | N&S Access Addition Bldng Cmmssng |  | 20d | 2011-01-21 | 2011-02-17 | 16111010N, 16111012 | 278d | 0d | PROCUREMENT<$50K 60 | 4,682.75 | WHITLATCH C | 1 | 1 |  | REBECCA Y |  |  |  |  |  | 10-028 | 11-055 | 12-029F | APP |  |  |  |  | 10-032 |  |  |  |
| 16111025 |  | N&S Access Addition Beneficial Occupancy |  | 20d | 2011-02-18 | 2011-03-18 | 16111015 | 278d | 0d | PLANT ENG [80 h] | 5,445.6 | WHITLATCH C | 1 | 1 |  | REBECCA Y |  |  |  |  |  | 10-028 | 11-055 | 12-029F |  |  |  |  |  | 10-032 |  |  |  |
| 16111030M |  | N&S Access Addition Constr Compltn | milestone | 0d | 2011-03-18 | 2011-03-18 | 16111025, 16111020a, 16111020 | 278d | 0d |  |  | WHITLATCH C | 1 | 1 |  | REBECCA Y |  |  |  |  | 6 | 10-028 | 11-055 | 12-029F |  |  |  |  |  | 10-032 |  |  |  |
| 16111035 |  | Re-Baseline Actuals Adjustment |  | 1d | 2013-08-30 | 2013-08-30 | 9-130M FS+227d | 20d |  | PROCUREMENT>$50K 69 NO ESCALATION | -106,587.34 | WHITLATCH C | 1 | 1 |  | REBECCA Y |  |  | 13-014 | ADJ |  |  |  |  |  |  |  |  |  |  |  |  |  |

| ID | WBS | Activity | Type | Duration | Start | Finish | Predecessors | Total float | Free float | Calendar | Resources | Cost | RESP - Responsibility | STRT%COMP for CM EVM | FNSH%COMP for CM EVM | CAM RESPONSIBLE | CR 10-020 | CR 11-016 | CR 12-015 | Milestone Level | CR 07-031 | Advance Purchase Plan > 500K | CR 08-014 | CR 08-016 | 12 GEV MAJOR PROCUREMENT CATAGORY | CR 09-012 | CR 10-032 | CR 07-029 | CR 12-001 | CR 13-014 | ReBaseline Actuals Adjustment | Original Activity ID Rebaseline | BOE Labor | BOE Adder | CR 13-015 | Post Rebaseline | CR 14-001 | BOE NOTES | BOE Procurement |
| --- | --- | --- | --- | --- | --- | --- | --- | --- | --- | --- | --- | --- | --- | --- | --- | --- | --- | --- | --- | --- | --- | --- | --- | --- | --- | --- | --- | --- | --- | --- | --- | --- | --- | --- | --- | --- | --- | --- | --- |
|  | 2 | **1.6.1.1.2 NORTH & SOUTH ACCESS BUILDING UTILITIES** |  |  | 2010-02-02 | 2015-10-02 |  |  |  |  |  |  |  |  |  |  |  |  |  |  |  |  |  |  |  |  |  |  |  |  |  |  |  |  |  |  |  |  |  |
| 16112000 |  | Redesign N&S Access LCW Upgrades |  | 105d | 2010-02-02 | 2010-06-30 | 9-100M FS+79d | 492d | 0d |  | MECH ENG [320 h]; ELEC ENG [160 h]; PLANT ENG [160 h]; SUPPLIES & MATERIALS | 45,230.4 | WHITLATCH C | 1 | 1 | REBECCA Y | 10-020 | 11-016 | 12-015 |  |  |  |  |  |  |  |  |  |  |  |  |  |  |  |  |  |  |  |  |
| 16112000M |  | N&S Access LCW Upgrades Begin Constr | milestone | 0d | 2010-07-01 | 2010-07-01 | 16112000, 1241195M, 1241075M | 492d | 0d |  |  |  | WHITLATCH C | 1 | 1 | REBECCA Y | 10-020 | 11-016 | 12-015 | 6 |  |  |  |  |  |  |  |  |  |  |  |  |  |  |  |  |  |  |  |
| 16112005 |  | N&S Access LCW Upgrades Award Contract |  | 60d | 2010-07-01 | 2010-09-24 | 16112000M | 492d | 0d |  | MECH ENG [80 h] | 5,268 | WHITLATCH C | 1 | 1 | REBECCA Y | 10-020 | 11-016 | 12-015 |  |  |  |  |  |  |  |  |  |  |  |  |  |  |  |  |  |  |  |  |
| 16112010 |  | West Arc LCW Header installation |  | 17d | 2010-12-01 | 2010-12-30 | 16112005, 16111025 FS-70d | 625d | 150d |  | PROCUREMENT<$50K 60; PROCUREMENT>$50K 69 | 250,000 | WHITLATCH C | 1 | 1 | REBECCA Y | 10-020 | 11-016 | 12-015 |  | 07-031 | APP | 08-014 | 08-016 | 6112 | 09-012 | 10-032 |  |  |  |  |  |  |  |  |  |  |  |  |
| 16112020 |  | N&S Access LCW Upgrades Constrctn Mngmnt FY11 |  | 207d | 2010-12-01 | 2011-09-30 | 16112005 FS+45d | 492d | 0d |  | OFFICE [236.57 h]; MECH DES [39.43 h]; MECH TECH [867.43 h]; ELEC ENG [394.29 h]; MECH ENG [1104 h]; PLANT ENG [276 h] | 166,512.36 | WHITLATCH C | 1 | 1 | REBECCA Y | 10-020 | 11-016 | 12-015 |  |  |  |  |  |  |  | 10-032 | 07-029 | 12-001 |  |  |  |  |  |  |  |  |  |  |
| 16112015 |  | N&S Access LCW Upgrades Bldng Cmmssng |  | 40d | 2011-08-05 | 2011-09-30 | 16112010, 1961000n FS-61d, 1961005 FS-61d | 475d | 0d |  | PROCUREMENT<$50K 60 | 45,353.46 | WHITLATCH C | 1 | 1 | REBECCA Y | 10-020 | 11-016 | 12-015 |  |  | APP |  |  |  |  | 10-032 |  |  |  |  |  |  |  |  |  |  |  |  |
| 16112020a |  | N&S Access LCW Upgrades Constrctn Mngmnt FY12 |  | 3d | 2011-10-03 | 2011-10-05 | 16112020 | 492d |  |  | MECH DES [0.57 h]; MECH TECH [12.57 h]; ELEC ENG [5.71 h]; MECH ENG [16 h]; PLANT ENG [4 h]; OFFICE [3.43 h] | 2,489.78 | WHITLATCH C | 1 | 1 | REBECCA Y | 10-020 | 11-016 | 12-015 |  |  |  |  |  |  |  | 10-032 | 07-029 | 12-001 |  |  |  |  |  |  |  |  |  |  |
| 16112025 |  | N&S Access LCW Upgrades Beneficial Occupancy |  | 20d | 2011-10-03 | 2011-10-28 | 16112015 | 475d |  |  | MECH ENG [80 h] | 5,609.6 | WHITLATCH C | 1 | 1 | REBECCA Y | 10-020 | 11-016 | 12-015 |  |  |  |  |  |  |  | 10-032 |  |  |  |  |  |  |  |  |  |  |  |  |
| 16112035 |  | Re-Baseline Actuals Adjustment |  | 1d | 2013-08-30 | 2013-08-30 | 9-130M FS+227d | 20d |  |  | PROCUREMENT>$50K 69 NO ESCALATION | 45,874.97 | WHITLATCH C | 1 | 1 | REBECCA Y |  |  |  |  |  |  |  |  |  |  |  |  |  | 13-014 | ADJ |  |  |  |  |  |  |  |  |
| 26112011 |  | Redundant Cooling Towers Award Contract |  | 60d | 2014-10-01 | 2015-01-06 | 9-155M | 56d | 0d | 8/5 M-F w/JLAB Holidays ReBaseline | MECH ENG [80 h] | 5,973.6 | YASKY R | 1 | 1 | REBECCA Y |  | 11-016 | 12-015 |  |  | APP |  |  | 6112 |  |  |  |  |  |  | 26112011 | EJ | NO | 13-015 | PR | 14-001 |  |  |
| 26112012 |  | Redundant Cooling Towers |  | 188d | 2015-01-07 | 2015-10-02 | 26112011 | 56d | 0d | 8/5 M-F w/JLAB Holidays ReBaseline | PROCUREMENT>$50K 69; PROCUREMENT<$50K 60 | 399,306.6 | YASKY R | 1 | 1 | REBECCA Y |  | 11-016 | 12-015 |  |  | APP |  |  | 6112 |  |  |  |  |  |  | 26112012 |  | YES | 13-015 | PR | 14-001 | -10% Bid previously | EV |
| 26112013 |  | Redundant Cooling Towers Construction Management |  | 187d | 2015-01-07 | 2015-10-01 | 26112011 | 57d | 1d | 8/5 M-F w/JLAB Holidays ReBaseline | MECH TECH [400 h]; MECH ENG [320 h]; OFFICE [80 h] | 45,254.4 | YASKY R | 1 | 1 | REBECCA Y |  | 11-016 | 12-015 |  |  | APP |  |  | 6112 |  |  |  |  |  |  | 26112013 | EJ | NO | 13-015 | PR | 14-001 |  |  |
| 26112030M |  | N&S Access LCW Upgrades Constr Comp | milestone | 0d | 2015-10-02 | 2015-10-02 | 26112012, 26112013 | 56d | 0d | 8/5 M-F w/JLAB Holidays ReBaseline |  |  | YASKY R | 1 | 1 | REBECCA Y | 10-020 | 11-016 | 12-015 | 6 |  |  |  |  |  |  | 10-032 |  |  |  |  | 26112030M |  |  | 13-015 | PR |  |  |  |
|  | 3 | **1.6.1.1.3 BEAM SWITCHYARD SERVICE BUILDING ADDITION** |  |  | 2010-10-01 | 2013-08-30 |  |  |  |  |  |  |  |  |  |  |  |  |  |  |  |  |  |  |  |  |  |  |  |  |  |  |  |  |  |  |  |  |  |
| 16113000M |  | BSY Addition Begin Constr | milestone | 0d | 2010-10-01 | 2010-10-01 | 9-110M, 1241115M | 49d | 0d |  |  |  | WHITLATCH C | 1 | 1 | REBECCA Y |  |  |  | 6 |  |  |  |  |  |  |  |  |  |  |  |  |  |  |  |  |  |  |  |
| 16113005 |  | BSY Addition Award Contract |  | 60d | 2010-10-01 | 2011-01-04 | 16113000M | 49d | 0d |  | PLANT ENG [80 h] | 5,445.6 | WHITLATCH C | 1 | 1 | REBECCA Y |  |  |  |  |  |  |  |  |  |  |  |  |  |  |  |  |  |  |  |  |  |  |  |
| 16113010 |  | BSY Addition Constrctn Contract Progress |  | 220d | 2011-01-05 | 2011-11-15 | 16113005 | 49d | 0d |  | PROCUREMENT>$50K 69 NO ESCALATION FY12; PROCUREMENT<$50K 60 NO ESCALATION FY12 | 208,625.92 | WHITLATCH C | 1 | 1 | REBECCA Y |  |  |  |  |  |  | 08-014 | 08-016 |  | 09-012 |  |  |  |  |  |  |  |  |  |  |  |  |  |
| 16113020 |  | BSY Addition Consrtuction Mngmnt FY11 |  | 188d | 2011-01-05 | 2011-09-30 | 16113005 | 956d | 0d |  | MECH TECH [644.57 h]; MECH DES [26.86 h]; PLANT ENG [617.71 h]; OFFICE [349.14 h]; ELEC ENG [53.71 h]; MECH ENG [53.71 h] | 88,045.95 | WHITLATCH C | 1 | 1 | REBECCA Y |  |  | 12-015 |  |  |  |  |  |  |  |  | 07-029 | 12-001 |  |  |  |  |  |  |  |  |  |  |
| 16113020a |  | BSY Addition Consrtuction Mngmnt FY12 |  | 92d | 2011-10-03 | 2012-02-21 | 16113020 | 956d | 0d |  | PLANT ENG [302.29 h]; OFFICE [170.86 h]; ELEC ENG [26.29 h]; MECH ENG [26.29 h]; MECH TECH [315.43 h]; MECH DES [13.14 h] | 44,460.03 | WHITLATCH C | 1 | 1 | REBECCA Y |  |  | 12-015 |  |  |  |  |  |  |  |  | 07-029 | 12-001 |  |  |  |  |  |  |  |  |  |  |
| 16113012 |  | BSY Modify LCW Piping |  | 20d | 2011-11-16 | 2011-12-15 | 16113010 | 69d | 20d |  | PROCUREMENT<$50K 60; MECH TECH [80 h]; MECH ENG [40 h] | 8,700.02 | WHITLATCH C | 1 | 1 | REBECCA Y |  |  |  |  |  |  |  |  |  |  |  |  |  |  |  |  |  |  |  |  |  |  |  |
| 16113015 |  | BSY Addition Bldng Cmmssng |  | 40d | 2011-11-16 | 2012-01-23 | 16113010 | 49d | 0d |  | PROCUREMENT<$50K 60 | 4,832.13 | WHITLATCH C | 1 | 1 | REBECCA Y |  |  |  |  |  |  |  |  |  |  |  |  |  |  |  |  |  |  |  |  |  |  |  |
| 16113025 |  | BSY Addition Beneficial Occupancy |  | 20d | 2012-01-24 | 2012-02-21 | 16113012, 16113015 | 49d | 0d |  | PLANT ENG [80 h] | 5,619.2 | WHITLATCH C | 1 | 1 | REBECCA Y |  |  |  |  |  |  |  |  |  |  |  |  |  |  |  |  |  |  |  |  |  |  |  |
| 16113030M |  | BSY Addition Constr Compltn | milestone | 0d | 2012-02-21 | 2012-02-21 | 16113025, 16113020a | 956d | 900d |  |  |  | WHITLATCH C | 1 | 1 | REBECCA Y |  |  | 12-015 | 6 |  |  |  |  |  |  |  |  |  |  |  |  |  |  |  |  |  |  |  |
| 16113035 |  | Re-Baseline Actuals Adjustment |  | 1d | 2013-08-30 | 2013-08-30 | 9-130M FS+227d | 20d |  |  | PROCUREMENT>$50K 69 NO ESCALATION | -95,702.62 | WHITLATCH C | 1 | 1 | REBECCA Y |  |  |  |  |  |  |  |  |  |  |  |  |  | 13-014 | ADJ |  |  |  |  |  |  |  |  |

| ID | WBS | Activity | Type | Duration | Start | Finish | Predecessors | Total float | Free float | Calendar | Resources | Cost | RESP - Responsibility | STRT%COMP for CM EVM | FNSH%COMP for CM EVM | CAM RESPONSIBLE | CR 13-014 | ReBaseline Actuals Adjustment | Original Activity ID Rebaseline | Milestone Level | CR 10-020 | CR 12-015 | Post Rebaseline | BOE Labor | BOE Adder | CR 13-015 | CR 14-001 | BOE NOTES | Advance Purchase Plan > 500K | CR 08-014 | CR 08-016 | 12 GEV MAJOR PROCUREMENT CATAGORY | CR 09-012 | BOE Procurement | CR 07-029 | CR 12-043 | Over Under Fixed | EVMS Reporting Codes | Obligated Prior to Rebaseline | CR 10-010 | CR 10-033 | CR 10-041 |
| --- | --- | --- | --- | --- | --- | --- | --- | --- | --- | --- | --- | --- | --- | --- | --- | --- | --- | --- | --- | --- | --- | --- | --- | --- | --- | --- | --- | --- | --- | --- | --- | --- | --- | --- | --- | --- | --- | --- | --- | --- | --- | --- |
|  | 4 | **1.6.1.1.4 TUNNEL AIR CONDITIONING** |  |  | 2013-08-30 | 2015-08-04 |  |  |  |  |  |  |  |  |  |  |  |  |  |  |  |  |  |  |  |  |  |  |  |  |  |  |  |  |  |  |  |  |  |  |  |  |
| 16114035 |  | Re-Baseline Actuals Adjustment |  | 1d | 2013-08-30 | 2013-08-30 | 9-130M FS+227d | 20d |  |  | PROCUREMENT>$50K 69 NO ESCALATION | 22,325.85 | WHITLATCH C | 1 | 1 | REBECCA Y | 13-014 | ADJ |  |  |  |  |  |  |  |  |  |  |  |  |  |  |  |  |  |  |  |  |  |  |  |  |
| 26114000M |  | Tunnel A/C Begin Constr | milestone | 0d | 2014-10-01 | 2014-10-01 | 9-155M | 98d | 0d | 8/5 M-F w/JLAB Holidays ReBaseline |  |  | YASKY R | 1 | 1 | REBECCA Y |  |  | 26114000M | 6 | 10-020 | 12-015 | PR |  |  |  |  |  |  |  |  |  |  |  |  |  |  |  |  |  |  |  |
| 26114005 |  | Tunnel A/C Award Contract |  | 65d | 2014-10-01 | 2015-01-13 | 26114000M | 98d | 0d | 8/5 M-F w/JLAB Holidays ReBaseline | MECH ENG [80 h] | 5,973.6 | YASKY R | 1 | 1 | REBECCA Y |  |  | 26114005 |  | 10-020 | 12-015 | PR | EJ | NO | 13-015 | 14-001 |  |  |  |  |  |  |  |  |  |  |  |  |  |  |  |
| 26114010 |  | Tunnel A/C Constrctn Contract Progress |  | 131d | 2015-01-14 | 2015-07-21 | 26114005 | 98d | 0d | 8/5 M-F w/JLAB Holidays ReBaseline | PROCUREMENT>$50K 69; PROCUREMENT<$50K 60 | 1,411,829.06 | YASKY R | 1 | 1 | REBECCA Y |  |  | 26114010 |  | 10-020 | 12-015 | PR |  | YES | 13-015 | 14-001 | +10% MEANS Est Manual | APP | 08-014 | 08-016 | 6114 | 09-012 | CP |  |  |  |  |  |  |  |  |
| 26114020 |  | Tunnel A/C Constrctn Mngmnt |  | 140d | 2015-01-14 | 2015-08-03 | 26114005 | 99d | 1d | 8/5 M-F w/JLAB Holidays ReBaseline | OFFICE [120 h]; ELEC ENG [40 h]; MECH ENG [640 h]; MECH TECH [520 h]; MECH DES [40 h] | 81,100.4 | YASKY R | 1 | 1 | REBECCA Y |  |  | 26114020 |  | 10-020 | 12-015 | PR | EJ | NO | 13-015 | 14-001 |  |  |  |  |  |  |  | 07-029 |  |  |  |  |  |  |  |
| 26114015 |  | Tunnel A/C Bldng Cmmssng |  | 5d | 2015-07-22 | 2015-07-28 | 26114010 | 98d | 0d | 8/5 M-F w/JLAB Holidays ReBaseline | PROCUREMENT<$50K 60 | 15,423.53 | YASKY R | 1 | 1 | REBECCA Y |  |  | 26114015 |  | 10-020 | 12-015 | PR |  | NO | 13-015 | 14-001 |  | APP |  |  |  |  | PE |  |  |  |  |  |  |  |  |
| 26114025 |  | Tunnel A/C Beneficial Occupancy |  | 5d | 2015-07-29 | 2015-08-04 | 26114015 | 98d | 0d | 8/5 M-F w/JLAB Holidays ReBaseline | MECH ENG [80 h] | 5,973.6 | YASKY R | 1 | 1 | REBECCA Y |  |  | 26114025 |  | 10-020 | 12-015 | PR | EJ | NO | 13-015 | 14-001 |  |  |  |  |  |  |  |  |  |  |  |  |  |  |  |
| 26114030M |  | Tunnel A/C Constr Comp | milestone | 0d | 2015-08-04 | 2015-08-04 | 26114020, 26114025 | 98d | 42d | 8/5 M-F w/JLAB Holidays ReBaseline |  |  | YASKY R | 1 | 1 | REBECCA Y |  |  | 26114030M | 6 | 10-020 | 12-015 | PR |  |  | 13-015 |  |  |  |  |  |  |  |  |  |  |  |  |  |  |  |  |
|  | 5 | **1.6.1.1.5. N&S LINAC SERVICE BUILDING AIR CONDITIONING** |  |  | 2012-10-01 | 2013-11-07 |  |  |  |  |  |  |  |  |  |  |  |  |  |  |  |  |  |  |  |  |  |  |  |  |  |  |  |  |  |  |  |  |  |  |  |  |
| 16115005 |  | Design N&S Linac A/C |  | 20d | 2012-10-01 | 2012-10-26 | 9-130M | 20d | 0d |  | MECH ENG [120 h]; ELEC ENG [40 h]; PLANT ENG [40 h]; MECH DES [80 h] | 18,471.6 | WHITLATCH C | 1 | 1 | REBECCA Y |  |  |  |  | 10-020 | 12-015 |  |  |  |  |  |  |  |  |  |  |  |  |  | 12-043 |  |  |  |  |  |  |
| 16115010 |  | Design and Safety Review of N&S Linac A/C |  | 10d | 2012-10-29 | 2012-11-09 | 16115005 | 20d | 0d |  | MECH ENG [40 h] | 2,894.4 | WHITLATCH C | 1 | 1 | REBECCA Y |  |  |  |  | 10-020 | 12-015 |  |  |  |  |  |  |  |  |  |  |  |  |  | 12-043 |  |  |  |  |  |  |
| 16115015 |  | Finalize Design N&S Linac A/C |  | 10d | 2012-11-12 | 2012-11-27 | 16115010 | 20d | 0d |  | MECH DES [40 h]; PLANT ENG [40 h]; MECH ENG [40 h]; ELEC ENG [40 h] | 10,694.4 | WHITLATCH C | 1 | 1 | REBECCA Y |  |  |  |  | 10-020 | 12-015 |  |  |  |  |  |  |  |  |  |  |  |  |  | 12-043 |  |  |  |  |  |  |
| 16115020 |  | N&S Linac A/C Award Const Contract |  | 60d | 2012-11-28 | 2013-03-01 | 16115015 | 20d | 0d |  | MECH ENG [80 h] | 5,788.8 | WHITLATCH C | 1 | 1 | REBECCA Y |  |  |  |  | 10-020 | 12-015 |  |  |  |  |  |  |  |  |  |  |  |  |  | 12-043 |  |  |  |  |  |  |
| 16115025 |  | N&S Linac A/C Construction Contract Progress |  | 128d | 2013-03-04 | 2013-08-30 | 16115020 | 20d |  |  | PROCUREMENT<$50K 60; PROCUREMENT>$50K 69 | 250,037.31 | WHITLATCH C | 1 | 1 | REBECCA Y | 13-014 |  |  |  | 10-020 | 12-015 |  |  |  |  |  |  |  |  |  |  |  |  |  | 12-043 |  |  |  |  |  |  |
| 16115030 |  | N&S Linac A/C Construction Management |  | 128d | 2013-03-04 | 2013-08-30 | 16115020 | 20d |  |  | MECH ENG [365.71 h]; ELEC ENG [73.14 h]; MECH TECH [329.14 h]; OFFICE [109.71 h] | 50,115.06 | WHITLATCH C | 1 | 1 | REBECCA Y | 13-014 |  |  |  | 10-020 | 12-015 |  |  |  |  |  |  |  |  |  |  |  |  |  | 12-043 |  |  |  |  |  |  |
| 16115050 |  | Re-Baseline Actuals Adjustment |  | 1d | 2013-08-30 | 2013-08-30 | 9-130M FS+227d | 20d |  |  | PROCUREMENT>$50K 69 NO ESCALATION | 8,479.85 | WHITLATCH C | 1 | 1 | REBECCA Y | 13-014 | ADJ |  |  |  |  |  |  |  |  |  |  |  |  |  |  |  |  |  |  |  |  |  |  |  |  |
| 26115025 |  | N&S Linac A/C Construction Contract Progress |  | 38d | 2013-09-03 | 2013-10-24 | 9-130M FS+228d | 523d | 0d | 8/5 M-F w/JLAB Holidays ReBaseline | PROCUREMENT<$50K 60 NO ESCALATION FY14; PROCUREMENT>$50K 69 NO ESCALATION FY14 | 52,634.11 | YASKY R | 1 | 1 | REBECCA Y |  |  | 26115025 |  | 10-020 | 12-015 | PR |  | YES | 13-015 |  | +10% MEANS Est Manual |  |  |  |  |  | CP |  | 12-043 | y | C | OB |  |  |  |
| 26115030 |  | N&S Linac A/C Construction Management FY13 |  | 20d | 2013-09-03 | 2013-09-30 | 26115025 FS-38d | 523d | 0d | 8/5 M-F w/JLAB Holidays ReBaseline | MECH ENG [57.15 h]; ELEC ENG [11.43 h]; MECH TECH [51.44 h]; OFFICE [17.14 h] | 7,831.49 | YASKY R | 1 | 1 | REBECCA Y |  |  | 26115030 |  | 10-020 | 12-015 | PR | EJ | NO | 13-015 |  |  |  |  |  |  |  |  |  | 12-043 |  | E |  |  |  |  |
| 26115030a |  | N&S Linac A/C Construction Management FY14 |  | 28d | 2013-10-01 | 2013-11-07 | 26115025 FS-38d, 26115030 | 523d | 0d | 8/5 M-F w/JLAB Holidays ReBaseline | MECH ENG [80.01 h]; ELEC ENG [16 h]; MECH TECH [72.01 h]; OFFICE [24 h] | 11,313.5 | YASKY R | 1 | 1 | REBECCA Y |  |  | 26115030 |  | 10-020 | 12-015 | PR | EJ | NO | 13-015 | 14-001 |  |  |  |  |  |  |  |  | 12-043 |  | E |  |  |  |  |
| 26115035 |  | N&S Linac A/C Building Commissioning |  | 5d | 2013-10-25 | 2013-10-31 | 26115025 | 523d | 0d | 8/5 M-F w/JLAB Holidays ReBaseline | MECH ENG [40 h] | 2,986.8 | YASKY R | 1 | 1 | REBECCA Y |  |  | 26115035 |  | 10-020 | 12-015 | PR | EJ | NO | 13-015 | 14-001 |  |  |  |  |  |  | PE |  | 12-043 |  | H |  |  |  |  |
| 26115040 |  | N&S Linac A/C Beneficial Occupancy |  | 5d | 2013-11-01 | 2013-11-07 | 26115035 | 523d | 0d | 8/5 M-F w/JLAB Holidays ReBaseline | MECH ENG [40 h] | 2,986.8 | YASKY R | 1 | 1 | REBECCA Y |  |  | 26115040 |  | 10-020 | 12-015 | PR | EJ | NO | 13-015 | 14-001 |  |  |  |  |  |  |  |  | 12-043 |  | H |  |  |  |  |
| 26115045M |  | N&S Linac A/C Construction Complete | milestone | 0d | 2013-11-07 | 2013-11-07 | 26115040, 26115030, 26115030a | 523d | 467d | 8/5 M-F w/JLAB Holidays ReBaseline |  |  | YASKY R | 1 | 1 | REBECCA Y |  |  | 26115045M |  | 10-020 | 12-015 | PR |  |  | 13-015 |  |  |  |  |  |  |  |  |  | 12-043 |  | M |  |  |  |  |
|  | 2 | **1.6.1.2 SITEWORK** |  |  | 2010-01-21 | 2013-08-30 |  |  |  |  |  |  |  |  |  |  |  |  |  |  |  |  |  |  |  |  |  |  |  |  |  |  |  |  |  |  |  |  |  |  |  |  |
|  | 1 | **1.6.1.2.1** |  |  |  |  |  |  |  |  |  |  |  |  |  |  |  |  |  |  |  |  |  |  |  |  |  |  |  |  |  |  |  |  |  |  |  |  |  |  |  |  |
|  | 2 | **1.6.1.2.2 ELECTRICAL DISTRIBUTION - N&S LINAC** |  |  | 2010-01-21 | 2013-08-30 |  |  |  |  |  |  |  |  |  |  |  |  |  |  |  |  |  |  |  |  |  |  |  |  |  |  |  |  |  |  |  |  |  |  |  |  |
| 16122010 |  | N&S Linac Constrctn Contract Progress (ED) May Progress Payment |  | 91d | 2010-01-21 | 2010-05-28 | 16122005 FS-250d, 9-100M FS+71d | 329d | 0d |  | PROCUREMENT<$50K 60 | 5,399 | WHITLATCH C | 1 | 1 | REBECCA Y |  |  |  |  |  |  |  |  |  |  |  |  | APP | 08-014 |  |  |  |  |  |  |  |  |  | 10-010 | 10-033 | 10-041 |
| 16122010A |  | N&S Linac Constrctn Contract Progress (ED) June Progress Payment |  | 113d | 2010-01-21 | 2010-06-30 | 16122010 FS-91d | 329d | 0d |  | PROCUREMENT<$50K 60; PROCUREMENT>$50K 69 | 51,585 | WHITLATCH C | 1 | 1 | REBECCA Y |  |  |  |  |  |  |  |  |  |  |  |  | APP |  |  |  |  |  |  |  |  |  |  |  |  | 10-041 |
| 16122010B |  | N&S Linac Constrctn Contract Progress (ED) July Progress Payment |  | 134d | 2010-01-21 | 2010-07-30 | 16122010A FS-113d | 329d | 0d |  | PROCUREMENT>$50K 69 | 123,003 | WHITLATCH C | 1 | 1 | REBECCA Y |  |  |  |  |  |  |  |  |  |  |  |  | APP |  |  |  |  |  |  |  |  |  |  |  |  | 10-041 |
| 16122010C |  | N&S Linac Constrctn Contract Progress (ED) August Progress Payment |  | 156d | 2010-01-21 | 2010-08-31 | 16122010B FS-134d | 329d | 0d |  | PROCUREMENT>$50K 69 | 322,250 | WHITLATCH C | 1 | 1 | REBECCA Y |  |  |  |  |  |  |  |  |  |  |  |  | APP |  |  |  |  |  |  |  |  |  |  |  |  | 10-041 |
| 16122010D |  | N&S Linac Constrctn Contract Progress (ED)September Progress Payment |  | 177d | 2010-01-21 | 2010-09-30 | 16122010C FS-156d | 329d | 0d |  | PROCUREMENT>$50K 69 | 14,763 | WHITLATCH C | 1 | 1 | REBECCA Y |  |  |  |  |  |  |  |  |  |  |  |  | APP |  |  |  |  |  |  |  |  |  |  |  |  | 10-041 |
| 16122012 |  | N&S Linac Constrctn Contract Modifications (ED) |  | 177d | 2010-01-21 | 2010-09-30 | 16122010D FS-177d | 329d | 0d |  | PROCUREMENT>$50K 69 NO ESCALATION | 26,000 | WHITLATCH C | 1 | 1 | REBECCA Y |  |  |  |  |  |  |  |  |  |  |  |  | APP |  |  |  |  |  |  |  |  |  |  |  | 10-033 | 10-041 |
| 16122020 |  | N&S Linac Constrctn Mngmnt (ED) |  | 173d | 2010-01-21 | 2010-09-24 | 16122005 FS-250d, 9-100M FS+71d | 1300d | 64d |  | MECH TECH [200 h]; MECH DES [40 h]; ELEC ENG [440 h]; OFFICE [120 h] | 42,533.6 | WHITLATCH C | 1 | 1 | REBECCA Y |  |  |  |  |  | 12-015 |  |  |  |  |  |  |  |  |  |  |  |  | 07-029 |  |  |  |  |  | 10-033 |  |
| 16122000M |  | Electrical Distrbtn N&S Linac Begin Constr | milestone | 0d | 2010-10-01 | 2010-10-01 | 1241195M, 9-110M | 342d | 0d |  |  |  | WHITLATCH C | 1 | 1 | REBECCA Y |  |  |  | 6 |  |  |  |  |  |  |  |  |  |  |  |  |  |  |  |  |  |  |  |  |  |  |
| 16122005 |  | N&S Linac Award Contract (ED) |  | 60d | 2010-10-01 | 2011-01-04 | 16122000M | 342d | 13d |  | ELEC ENG [80 h] | 5,470.4 | WHITLATCH C | 1 | 1 | REBECCA Y |  |  |  |  |  |  |  |  |  |  |  |  |  |  |  |  |  |  |  |  |  |  |  |  |  |  |
| 16122015 |  | N&S Linac Bldng Cmmssng (ED) |  | 40d | 2010-10-01 | 2010-11-29 | 16122010D, 16122012, 16122010 | 329d | 0d |  | PROCUREMENT<$50K 60 | 11,701.2 | WHITLATCH C | 1 | 1 | REBECCA Y |  |  |  |  |  |  |  |  |  |  |  |  |  |  |  |  |  |  |  |  |  |  |  |  | 10-033 | 10-041 |
| 16122025 |  | N&S Linac Beneficial Occupancy (ED) |  | 20d | 2010-11-30 | 2011-01-04 | 16122015 | 329d | 0d |  | ELEC ENG [40 h] | 2,735.2 | WHITLATCH C | 1 | 1 | REBECCA Y |  |  |  |  |  |  |  |  |  |  |  |  |  |  |  |  |  |  |  |  |  |  |  |  | 10-033 | 10-041 |
| 16122030M |  | Electrical Distrbtn N&S Linac Constr Comp | milestone | 0d | 2011-01-04 | 2011-01-04 | 16122020, 16122025 | 1236d | 1180d |  |  |  | WHITLATCH C | 1 | 1 | REBECCA Y |  |  |  | 6 |  | 12-015 |  |  |  |  |  |  |  |  |  |  |  |  |  |  |  |  |  |  | 10-033 | 10-041 |
| 16122035 |  | Re-Baseline Actuals Adjustment |  | 1d | 2013-08-30 | 2013-08-30 | 9-130M FS+227d | 20d |  |  | PROCUREMENT>$50K 69 NO ESCALATION | -17,055.89 | WHITLATCH C | 1 | 1 | REBECCA Y | 13-014 | ADJ |  |  |  |  |  |  |  |  |  |  |  |  |  |  |  |  |  |  |  |  |  |  |  |  |

| ID | WBS | Activity | Type | Duration | Start | Finish | Predecessors | Total float | Free float | Resources | Cost | RESP - Responsibility | STRT%COMP for CM EVM | FNSH%COMP for CM EVM | CR 09-009 | Advance Purchase Plan > 500K | CR 08-014 | CR 08-016 | CAM RESPONSIBLE | 12 GEV MAJOR PROCUREMENT CATAGORY | CR 07-029 | CR 10-001 | CR 09-012 | CR 09-024 | CR 09-009A | CR 08-058 | CR 09-036 | CR 12-018 | CR 12-029 | CR 12-032 | CR 12-015 | CR 13-014 | ReBaseline Actuals Adjustment | Milestone Level | CR 10-021 | CR 10-058 | CR 10-071 | CR 11-001 |
| --- | --- | --- | --- | --- | --- | --- | --- | --- | --- | --- | --- | --- | --- | --- | --- | --- | --- | --- | --- | --- | --- | --- | --- | --- | --- | --- | --- | --- | --- | --- | --- | --- | --- | --- | --- | --- | --- | --- |
|  | 3 | **1.6.1.2.3** |  |  |  |  |  |  |  |  |  |  |  |  |  |  |  |  |  |  |  |  |  |  |  |  |  |  |  |  |  |  |  |  |  |  |  |  |
|  | 4 | **1.6.1.2.4** |  |  |  |  |  |  |  |  |  |  |  |  |  |  |  |  |  |  |  |  |  |  |  |  |  |  |  |  |  |  |  |  |  |  |  |  |
|  | 5 | **1.6.1.2.5** |  |  |  |  |  |  |  |  |  |  |  |  |  |  |  |  |  |  |  |  |  |  |  |  |  |  |  |  |  |  |  |  |  |  |  |  |
|  | 6 | **1.6.1.2.6** |  |  |  |  |  |  |  |  |  |  |  |  |  |  |  |  |  |  |  |  |  |  |  |  |  |  |  |  |  |  |  |  |  |  |  |  |
|  | 7 | **1.6.1.2.7** |  |  |  |  |  |  |  |  |  |  |  |  |  |  |  |  |  |  |  |  |  |  |  |  |  |  |  |  |  |  |  |  |  |  |  |  |
|  | 2 | **1.6.2 CHL** |  |  | 2008-12-12 | 2013-08-30 |  |  |  |  |  |  |  |  |  |  |  |  |  |  |  |  |  |  |  |  |  |  |  |  |  |  |  |  |  |  |  |  |
|  | 1 | **1.6.2.1 CHL BUILDING ADDITION** |  |  | 2008-12-12 | 2013-08-30 |  |  |  |  |  |  |  |  |  |  |  |  |  |  |  |  |  |  |  |  |  |  |  |  |  |  |  |  |  |  |  |  |
| 1621009 |  | CHL Addition Constrctn Contract Award (BONDS) |  | 5d | 2008-12-12 | 2008-12-18 | 3C-04M FS-20d, 1621005 FS-20d | 141d | 0d | PROCUREMENT<$50K 60; PROCUREMENT>$50K 69 | 50,000 | CHANDRA S | 1 | 1 | 09-009 | APP | 08-014 | 08-016 | REBECCA Y | 621 |  |  |  |  |  |  |  |  |  |  |  |  |  |  |  |  |  |  |
| 1621015 |  | CHL Addition Constrctn Mngmnt FY09 |  | 198d | 2008-12-12 | 2009-09-30 | 1621005 FS-20d | 334d | 0d | ELEC ENG [29.33 h]; MECH ENG [29.33 h]; PLANT ENG [674.67 h]; OFFICE [176 h]; MECH TECH [1114.67 h]; MECH DES [29.33 h] | 97,833.78 | CHANDRA S | 1 | 1 | 09-009 |  |  |  | REBECCA Y |  | 07-029 | 10-001B |  |  |  |  |  |  |  |  |  |  |  |  |  |  |  |  |
| 1621020 |  | CHL Addition A/E Supprt |  | 270d | 2008-12-12 | 2010-01-21 | 1621005 FS-20d | 334d | 294d | PROCUREMENT<$50K 60 NO ESCALATION; PROCUREMENT>$50K 69 NO ESCALATION | 61,540.07 | CHANDRA S | 1 | 1 | 09-009 | APP |  | 08-016 | REBECCA Y | 621 |  | 10-001A | 09-012 |  |  |  |  |  |  |  |  |  |  |  |  |  |  |  |
| 1621010 |  | CHL Addition Constrctn Contract Progress |  | 240d | 2008-12-19 | 2009-12-08 | 1621009 | 141d | 0d | PROCUREMENT<$50K 60 NO ESCALATION; PROCUREMENT>$50K 69 NO ESCALATION | 1,502,200 | CHANDRA S | 1 | 1 | 09-009 | APP | 08-014 | 08-016 | REBECCA Y | 621 |  | 10-001A | 09-012 | 09-024 | 09-009A |  |  |  |  |  |  |  |  |  |  |  |  |  |
| 1621005 |  | Prcrmnt Prep for CHL Addition to Award Contract |  | 11d | 2009-01-02 | 2009-01-16 | 1621005X | 72d | 0d | PLANT ENG [12.57 h] | 803.6 | CHANDRA S | 1 | 1 |  |  |  |  | REBECCA Y |  |  |  |  |  |  | 08-058 |  |  |  |  |  |  |  |  |  |  |  |  |
| 1621011LOE |  | PPI Adjustment FY09 |  | 86d | 2009-06-01 | 2009-09-30 | 9-090M FS+162d | 575d | 0d | SUPPLIES & MATERIALS | 12,728 | CHANDRA S | 1 | 1 |  | APP |  |  | REBECCA Y | 621 |  | 10-001B |  |  |  |  | 09-036 | 12-018F | 12-029F | 12-032F |  |  |  |  |  |  |  |  |
| 1621011LOEb |  | PPI Adjustment FY10 |  | 47d | 2009-10-01 | 2009-12-08 | 1621011LOE | 575d | 0d | SUPPLIES & MATERIALS | 7,177.9 | CHANDRA S | 1 | 1 |  | APP |  |  | REBECCA Y | 621 |  | 10-001B |  |  |  |  |  | 12-018F | 12-029F | 12-032F |  |  |  |  |  |  |  |  |
| 1621015b |  | CHL Addition Constrctn Mngmnt FY10 |  | 72d | 2009-10-01 | 2010-01-21 | 1621015 | 334d | 294d | MECH TECH [405.33 h]; MECH DES [10.67 h]; ELEC ENG [10.67 h]; MECH ENG [10.67 h]; PLANT ENG [245.33 h]; OFFICE [64 h] | 36,711.16 | CHANDRA S | 1 | 1 |  |  |  |  | REBECCA Y |  |  | 10-001B |  |  |  |  |  |  |  |  |  |  |  |  |  |  |  |  |
| 1621025 |  | CHl Addition Cmmssng |  | 20d | 2009-12-09 | 2010-01-13 | 1621010, 1621011LOEb | 575d | 0d | PROCUREMENT<$50K 60 NO ESCALATION | 19,784.31 | CHANDRA S | 1 | 1 | 09-009 | APP |  |  | REBECCA Y | 621 |  | 10-001A |  |  |  |  |  | 12-018F | 12-029F | 12-032F |  |  |  |  |  |  |  |  |
| 1621030 |  | CHL Addition Beneficial Occupancy |  | 5d | 2010-01-14 | 2010-01-21 | 1621025 | 1472d | 1416d | PLANT ENG [40 h] | 2,638.8 | CHANDRA S | 1 | 1 | 09-009 |  |  |  | REBECCA Y |  |  |  |  |  |  |  |  |  |  |  | 12-015 |  |  |  |  |  |  |  |
| 1621035 |  | Re-Baseline Actuals Adjustment |  | 1d | 2013-08-30 | 2013-08-30 | 9-130M FS+227d | 20d |  | PROCUREMENT>$50K 69 NO ESCALATION | 1,304.44 | CHANDRA S | 1 | 1 |  |  |  |  | REBECCA Y |  |  |  |  |  |  |  |  |  |  |  |  | 13-014 | ADJ |  |  |  |  |  |
|  | 2 | **1.6.2.2 SITEWORK** |  |  | 2009-10-01 | 2013-08-30 |  |  |  |  |  |  |  |  |  |  |  |  |  |  |  |  |  |  |  |  |  |  |  |  |  |  |  |  |  |  |  |  |
| 1622000 |  | Re-Baseline Actuals Adjustment |  | 1d | 2013-08-30 | 2013-08-30 | 9-130M FS+227d | 20d |  | PROCUREMENT>$50K 69 NO ESCALATION | -145,495.64 | CHANDRA S | 1 | 1 |  |  |  |  | REBECCA Y |  |  |  |  |  |  |  |  |  |  |  |  | 13-014 | ADJ |  |  |  |  |  |
|  | 1 | **1.6.2.2.1** |  |  |  |  |  |  |  |  |  |  |  |  |  |  |  |  |  |  |  |  |  |  |  |  |  |  |  |  |  |  |  |  |  |  |  |  |
|  | 2 | **1.6.2.2.2 ELECTRICAL DISTRIBUTION** |  |  | 2009-10-01 | 2011-05-27 |  |  |  |  |  |  |  |  |  |  |  |  |  |  |  |  |  |  |  |  |  |  |  |  |  |  |  |  |  |  |  |  |
| 16222000M |  | Electrical Distrbtn Begin Constr | milestone | 0d | 2009-10-01 | 2009-10-01 | 16222000 FS-130d, 9-100M | 62d | 0d |  |  | CHANDRA S | 1 | 1 |  |  |  |  | REBECCA Y |  |  |  |  |  |  |  |  |  |  |  |  |  |  | 6 | 10-021 | 10-058 |  |  |
| 16222007 |  | Elect Distrbtn Original Labor |  | 130d | 2009-10-01 | 2010-04-14 | 16222000M | 62d | 39d | ELEC ENG [80 h] | 5,301.6 | CHANDRA S | 1 | 1 |  | APP |  |  | REBECCA Y | 6222A |  |  |  |  |  |  |  |  |  |  |  |  |  |  | 10-021 | 10-058 |  |  |
| 16222000 |  | Redesign CHL Utilities Upgrades |  | 51d | 2010-02-01 | 2010-04-13 | 9-100M FS+78d | 23d | 0d | ELEC ENG [120 h]; PLANT ENG [40 h]; PROCUREMENT<$50K 60; PROCUREMENT>$50K 69; MECH ENG [240 h] | 96,395.2 | CHANDRA S | 1 | 1 |  |  |  |  | REBECCA Y |  |  |  |  |  |  |  |  |  |  |  |  |  |  |  | 10-021 |  |  |  |
| 16222032 |  | Elect Distrbtn 40 MVA Switchgear Modification Labor Original |  | 84d | 2010-02-01 | 2010-05-28 | 9-100M FS+78d | 270d | 247d | MECH TECH [118.59 h]; ELEC ENG [138.35 h]; OFFICE [39.53 h] | 15,178.2 | CHANDRA S | 1 | 1 |  |  |  |  | REBECCA Y |  |  |  |  |  |  |  |  |  |  |  |  |  |  |  | 10-021 | 10-058 |  |  |
| 16222005 |  | Elect Distrbtn Award Contract |  | 40d | 2010-04-14 | 2010-06-09 | 16222000M, 16222000 | 23d | 0d | MECH ENG [40 h] | 2,634 | CHANDRA S | 1 | 1 |  |  |  |  | REBECCA Y |  |  |  |  |  |  |  |  |  |  |  |  |  |  |  | 10-021 |  |  |  |
| 16222009 |  | CHL Utility Upgrades Modifications |  | 220d | 2010-06-10 | 2011-04-29 | 16222005, 16222007 | 23d | 0d | PROCUREMENT>$50K 69 NO ESCALATION; PROCUREMENT<$50K 60 NO ESCALATION | 112,000 | CHANDRA S | 1 | 1 |  | APP |  |  | REBECCA Y | 6222A |  |  |  |  |  |  |  |  |  |  |  |  |  |  |  | 10-058 |  |  |
| 16222010 |  | CHL Utility Upgrades Contract Progress July 2010 |  | 36d | 2010-06-10 | 2010-07-30 | 16222007, 16222005 | 23d | 0d | PROCUREMENT>$50K 69 NO ESCALATION; PROCUREMENT<$50K 60 NO ESCALATION | 59,860 | CHANDRA S | 1 | 1 |  | APP | 08-014 |  | REBECCA Y | 6222B |  |  |  |  |  |  |  |  |  |  |  |  |  |  | 10-021 | 10-058 | 10-071 |  |
| 16222010A |  | CHL Utility Upgrades Contract Progress August 2010 |  | 58d | 2010-06-10 | 2010-08-31 | 16222010 FS-36d | 23d | 0d | PROCUREMENT>$50K 69 NO ESCALATION | 112,880 | CHANDRA S | 1 | 1 |  | APP |  |  | REBECCA Y | 6222B |  |  |  |  |  |  |  |  |  |  |  |  |  |  |  |  | 10-071 |  |
| 16222010B |  | CHL Utility Upgrades Contract Progress September 2010 |  | 79d | 2010-06-10 | 2010-09-30 | 16222010A FS-58d | 23d | 0d | PROCUREMENT>$50K 69 NO ESCALATION | 87,580 | CHANDRA S | 1 | 1 |  | APP |  |  | REBECCA Y | 6222B |  |  |  |  |  |  |  |  |  |  |  |  |  |  |  |  | 10-071 |  |
| 16222010C |  | CHL Utility Upgrades Contract Progress October 2010 |  | 100d | 2010-06-10 | 2010-10-29 | 16222010B FS-79d | 23d | 0d | PROCUREMENT>$50K 69 NO ESCALATION | 83,270 | CHANDRA S | 1 | 1 |  | APP |  |  | REBECCA Y | 6222B |  |  |  |  |  |  |  |  |  |  |  |  |  |  |  |  | 10-071 |  |
| 16222010D |  | CHL Utility Upgrades Contract Progress November 2010 |  | 120d | 2010-06-10 | 2010-11-30 | 16222010C FS-100d | 23d | 0d | PROCUREMENT>$50K 69 NO ESCALATION | 505,450 | CHANDRA S | 1 | 1 |  | APP |  |  | REBECCA Y | 6222B |  |  |  |  |  |  |  |  |  |  |  |  |  |  |  |  | 10-071 |  |
| 16222010F |  | CHL Utility Upgrades Contract Progress December 2010 |  | 137d | 2010-06-10 | 2010-12-30 | 16222010D FS-120d | 23d | 0d | PROCUREMENT>$50K 69 NO ESCALATION | 609,380 | CHANDRA S | 1 | 1 |  | APP |  |  | REBECCA Y | 6222B |  |  |  |  |  |  |  |  |  |  |  |  |  |  |  |  | 10-071 |  |
| 16222010G |  | CHL Utility Upgrades Contract Progress January 2010 |  | 157d | 2010-06-10 | 2011-01-31 | 16222010F FS-137d | 23d | 0d | PROCUREMENT>$50K 69 NO ESCALATION | 413,000 | CHANDRA S | 1 | 1 |  | APP |  |  | REBECCA Y | 6222B |  |  |  |  |  |  |  |  |  |  |  |  |  |  |  |  | 10-071 |  |
| 16222010H |  | CHL Utility Upgrades Contract Progress February 2010 |  | 176d | 2010-06-10 | 2011-02-28 | 16222010G FS-157d | 23d | 0d | PROCUREMENT>$50K 69 NO ESCALATION | 175,780 | CHANDRA S | 1 | 1 |  | APP |  |  | REBECCA Y | 6222B |  |  |  |  |  |  |  |  |  |  |  |  |  |  |  |  | 10-071 |  |
| 16222010J |  | CHL Utility Upgrades Contract Progress March 2010 |  | 199d | 2010-06-10 | 2011-03-31 | 16222010H FS-176d | 23d | 0d | PROCUREMENT>$50K 69 NO ESCALATION | 124,650 | CHANDRA S | 1 | 1 |  | APP |  |  | REBECCA Y | 6222B |  |  |  |  |  |  |  |  |  |  |  |  |  |  |  |  | 10-071 |  |
| 16222010K |  | CHL Utility Upgrades Contract Progress April 2010 |  | 220d | 2010-06-10 | 2011-04-29 | 16222010J FS-199d | 23d | 0d | PROCUREMENT>$50K 69 NO ESCALATION | 65,150 | CHANDRA S | 1 | 1 |  | APP |  |  | REBECCA Y | 6222B |  |  |  |  |  |  |  |  |  |  |  |  |  |  |  |  | 10-071 |  |
| 16222015 |  | CHL Utility Upgrades Mngmnt FY10 |  | 79d | 2010-06-10 | 2010-09-30 | 16222005 | 23d | 0d | MECH DES [26.33 h]; MECH TECH [434.96 h]; OFFICE [92.32 h]; ELEC ENG [59.79 h]; MECH ENG [276.5 h]; PLANT ENG [13.17 h] | 44,860.13 | CHANDRA S | 1 | 1 |  |  |  |  | REBECCA Y |  | 07-029 |  |  |  |  |  |  |  |  |  |  |  |  |  | 10-021 | 10-058 |  | 11-001 |
| 16222020 |  | CHL Utility Upgrades A/E Supprt |  | 240d | 2010-06-10 | 2011-05-27 | 16222005 | 23d | 0d | PROCUREMENT<$50K 60 NO ESCALATION FY11 | 28,000 | CHANDRA S | 1 | 1 |  | APP |  | 08-016 | REBECCA Y |  |  |  | 09-012 |  |  |  |  |  |  |  |  |  |  |  | 10-021 | 10-058 |  |  |
| 16222015a |  | CHL Utility Upgrades Mngmnt FY11 |  | 161d | 2010-10-01 | 2011-05-27 | 16222015 | 23d | 0d | MECH DES [53.67 h]; MECH TECH [886.45 h]; OFFICE [188.15 h]; ELEC ENG [121.86 h]; MECH ENG [563.5 h]; PLANT ENG [26.83 h] | 94,339.77 | CHANDRA S | 1 | 1 |  |  |  |  | REBECCA Y |  | 07-029 |  |  |  |  |  |  |  |  |  |  |  |  |  | 10-021 | 10-058 |  | 11-001 |
| 16222025 |  | CHL Utility Upgrades Cmmssng |  | 20d | 2011-04-04 | 2011-04-29 | 16222009 FS-20d, 16222010K FS-20d | 23d | 0d | PROCUREMENT<$50K 60 | 16,383.94 | CHANDRA S | 1 | 1 |  | APP |  |  | REBECCA Y |  |  |  |  |  |  |  |  |  |  |  |  |  |  |  | 10-021 | 10-058 |  |  |
| 16222030 |  | CHL Utility Upgrades Beneficial Occupancy |  | 20d | 2011-05-02 | 2011-05-27 | 16222025 | 23d | 0d | MECH ENG [80 h] | 5,436 | CHANDRA S | 1 | 1 |  |  |  |  | REBECCA Y |  |  |  |  |  |  |  |  |  |  |  |  |  |  |  | 10-021 | 10-058 |  |  |
| 16222035M |  | CHL Utility Upgrades Complete | milestone | 0d | 2011-05-27 | 2011-05-27 | 16222030, 16222032, 16223007, 16222015a, 16222020, 16223005 | 23d | 0d |  |  | CHANDRA S | 1 | 1 |  |  |  |  | REBECCA Y |  |  |  |  |  |  |  |  |  |  |  |  |  |  | 6 | 10-021 | 10-058 |  |  |

Notes:
- 16222000M: Entry Criteria: Predecessor 1242040M (CHL Design / Completed)

| ID | WBS | Activity | Type | Duration | Start | Finish | Predecessors | Total float | Free float | Resources | Cost | RESP - Responsibility | STRT%COMP for CM EVM | FNSH%COMP for CM EVM | Milestone Level | CAM RESPONSIBLE | CR 10-021 | CR 10-058 | Advance Purchase Plan > 500K | 12 GEV MAJOR PROCUREMENT CATAGORY | 12 GeV 3rd level Critical Path | HALL D Related Milestones | CIVIL CRITICAL MILESTONES | CR 08-023 | CR 09-010 | CR 09-007 | CR 10-042 | CR 10-061 | CR 08-017 | CR 09-012 | CR 07-024 | CR 08-014 | CR 08-016 | CR 08-055 | CR 09-010A | CR 09-038 | CR 09-044 | CR 10-051 | CR 10-001 | CR 07-029 | CR 09-011 | CR 12-015 | CR 08-034 | CR 13-014 | ReBaseline Actuals Adjustment |
| --- | --- | --- | --- | --- | --- | --- | --- | --- | --- | --- | --- | --- | --- | --- | --- | --- | --- | --- | --- | --- | --- | --- | --- | --- | --- | --- | --- | --- | --- | --- | --- | --- | --- | --- | --- | --- | --- | --- | --- | --- | --- | --- | --- | --- | --- |
|  | 3 | **1.6.2.2.3 COOLING WATER** |  |  | 2009-10-01 | 2010-02-03 |  |  |  |  |  |  |  |  |  |  |  |  |  |  |  |  |  |  |  |  |  |  |  |  |  |  |  |  |  |  |  |  |  |  |  |  |  |  |  |
| 16223000M |  | Cooling Water Tower Begin Constr | milestone | 0d | 2009-10-01 | 2009-10-01 | 9-100M, 16222000 FS-130d | 352d | 0d |  |  | CHANDRA S | 1 | 1 | 6 | REBECCA Y | 10-021 | 10-058 |  |  |  |  |  |  |  |  |  |  |  |  |  |  |  |  |  |  |  |  |  |  |  |  |  |  |  |
| 16223007 |  | Cooling Water Tower Original Labor |  | 80d | 2009-10-01 | 2010-02-02 | 16223000M | 352d | 329d | PROCUREMENT>$50K 69; MECH ENG [80 h] | 147,122.2 | CHANDRA S | 1 | 1 |  | REBECCA Y | 10-021 | 10-058 | APP | 6223 |  |  |  |  |  |  |  |  |  |  |  |  |  |  |  |  |  |  |  |  |  |  |  |  |  |
| 16223005 |  | Cooling Water Tower Award Contract |  | 70d | 2009-10-15 | 2010-02-02 | 16223000M FS+10d | 352d | 329d | MECH ENG [40 h] | 2,634 | CHANDRA S | 1 | 1 |  | REBECCA Y | 10-021 | 10-058 |  |  |  |  |  |  |  |  |  |  |  |  |  |  |  |  |  |  |  |  |  |  |  |  |  |  |  |
| 16223008 |  | Reverse Entry per CR10-021 P6 5% Spread Fix |  | 1d | 2010-02-03 | 2010-02-03 | 9-100M FS+80d | 167d |  | PROCUREMENT>$50K 69 | -141,854.2 | CHANDRA S | 1 | 1 |  | REBECCA Y | 10-021 |  | APP | 6223 |  |  |  |  |  |  |  |  |  |  |  |  |  |  |  |  |  |  |  |  |  |  |  |  |  |
|  | 4 | **1.6.2.2.4** |  |  |  |  |  |  |  |  |  |  |  |  |  |  |  |  |  |  |  |  |  |  |  |  |  |  |  |  |  |  |  |  |  |  |  |  |  |  |  |  |  |  |  |
|  | 5 | **1.6.2.2.5** |  |  |  |  |  |  |  |  |  |  |  |  |  |  |  |  |  |  |  |  |  |  |  |  |  |  |  |  |  |  |  |  |  |  |  |  |  |  |  |  |  |  |  |
|  | 6 | **1.6.2.2.6** |  |  |  |  |  |  |  |  |  |  |  |  |  |  |  |  |  |  |  |  |  |  |  |  |  |  |  |  |  |  |  |  |  |  |  |  |  |  |  |  |  |  |  |
|  | 7 | **1.6.2.2.7** |  |  |  |  |  |  |  |  |  |  |  |  |  |  |  |  |  |  |  |  |  |  |  |  |  |  |  |  |  |  |  |  |  |  |  |  |  |  |  |  |  |  |  |
|  | 3 | **1.6.3 HALL D** |  |  | 2009-02-02 | 2013-08-30 |  |  |  |  |  |  |  |  |  |  |  |  |  |  |  |  |  |  |  |  |  |  |  |  |  |  |  |  |  |  |  |  |  |  |  |  |  |  |  |
|  | 1 | **1.6.3.1 TUNNEL & BUILDINGS** |  |  |  |  |  |  |  |  |  |  |  |  |  |  |  |  |  |  |  |  |  |  |  |  |  |  |  |  |  |  |  |  |  |  |  |  |  |  |  |  |  |  |  |
|  | 1 | **1.6.3.1.1 HALL D** |  |  |  |  |  |  |  |  |  |  |  |  |  |  |  |  |  |  |  |  |  |  |  |  |  |  |  |  |  |  |  |  |  |  |  |  |  |  |  |  |  |  |  |
|  | 2 | **1.6.3.1.2 TUNNEL EXTENSION** |  |  |  |  |  |  |  |  |  |  |  |  |  |  |  |  |  |  |  |  |  |  |  |  |  |  |  |  |  |  |  |  |  |  |  |  |  |  |  |  |  |  |  |
|  | 3 | **1.6.3.1.3 COUNTING HOUSE** |  |  |  |  |  |  |  |  |  |  |  |  |  |  |  |  |  |  |  |  |  |  |  |  |  |  |  |  |  |  |  |  |  |  |  |  |  |  |  |  |  |  |  |
|  | 4 | **1.6.3.1.4 TAGGER AREA** |  |  |  |  |  |  |  |  |  |  |  |  |  |  |  |  |  |  |  |  |  |  |  |  |  |  |  |  |  |  |  |  |  |  |  |  |  |  |  |  |  |  |  |
|  | 5 | **1.6.3.1.5 SERVICE BUILDINGS** |  |  |  |  |  |  |  |  |  |  |  |  |  |  |  |  |  |  |  |  |  |  |  |  |  |  |  |  |  |  |  |  |  |  |  |  |  |  |  |  |  |  |  |
|  | 6 | **1.6.3.1.6 CRYO PLANT** |  |  |  |  |  |  |  |  |  |  |  |  |  |  |  |  |  |  |  |  |  |  |  |  |  |  |  |  |  |  |  |  |  |  |  |  |  |  |  |  |  |  |  |
|  | 7 | **1.6.3.1.7 BEAM DUMP** |  |  |  |  |  |  |  |  |  |  |  |  |  |  |  |  |  |  |  |  |  |  |  |  |  |  |  |  |  |  |  |  |  |  |  |  |  |  |  |  |  |  |  |
|  | 2 | **1.6.3.2 SITEWORK** |  |  |  |  |  |  |  |  |  |  |  |  |  |  |  |  |  |  |  |  |  |  |  |  |  |  |  |  |  |  |  |  |  |  |  |  |  |  |  |  |  |  |  |
|  | 1 | **1.6.3.2.1 CIVIL UTILITIES** |  |  |  |  |  |  |  |  |  |  |  |  |  |  |  |  |  |  |  |  |  |  |  |  |  |  |  |  |  |  |  |  |  |  |  |  |  |  |  |  |  |  |  |
|  | 2 | **1.6.3.2.2 ELECTRICAL UTILITIES** |  |  |  |  |  |  |  |  |  |  |  |  |  |  |  |  |  |  |  |  |  |  |  |  |  |  |  |  |  |  |  |  |  |  |  |  |  |  |  |  |  |  |  |
|  | 3 | **1.6.3.2.3 COOLING WATER** |  |  |  |  |  |  |  |  |  |  |  |  |  |  |  |  |  |  |  |  |  |  |  |  |  |  |  |  |  |  |  |  |  |  |  |  |  |  |  |  |  |  |  |
|  | 4 | **1.6.3.2.4** |  |  |  |  |  |  |  |  |  |  |  |  |  |  |  |  |  |  |  |  |  |  |  |  |  |  |  |  |  |  |  |  |  |  |  |  |  |  |  |  |  |  |  |
|  | 5 | **1.6.3.2.5 SITE PREP, ROADS, & PARKING** |  |  |  |  |  |  |  |  |  |  |  |  |  |  |  |  |  |  |  |  |  |  |  |  |  |  |  |  |  |  |  |  |  |  |  |  |  |  |  |  |  |  |  |
|  | 6 | **1.6.3.2.6** |  |  |  |  |  |  |  |  |  |  |  |  |  |  |  |  |  |  |  |  |  |  |  |  |  |  |  |  |  |  |  |  |  |  |  |  |  |  |  |  |  |  |  |
|  | 7 | **1.6.3.2.7** |  |  |  |  |  |  |  |  |  |  |  |  |  |  |  |  |  |  |  |  |  |  |  |  |  |  |  |  |  |  |  |  |  |  |  |  |  |  |  |  |  |  |  |
|  | 8 | **1.6.3.2.8** |  |  |  |  |  |  |  |  |  |  |  |  |  |  |  |  |  |  |  |  |  |  |  |  |  |  |  |  |  |  |  |  |  |  |  |  |  |  |  |  |  |  |  |
|  | 9 | **1.6.3.2.9** |  |  |  |  |  |  |  |  |  |  |  |  |  |  |  |  |  |  |  |  |  |  |  |  |  |  |  |  |  |  |  |  |  |  |  |  |  |  |  |  |  |  |  |
|  | 3 | **1.6.3.3 CONSTRUCTION** |  |  | 2009-02-02 | 2013-08-30 |  |  |  |  |  |  |  |  |  |  |  |  |  |  |  |  |  |  |  |  |  |  |  |  |  |  |  |  |  |  |  |  |  |  |  |  |  |  |  |
|  | 1 | **1.6.3.3.1 PHASE 1** |  |  | 2009-02-02 | 2013-08-30 |  |  |  |  |  |  |  |  |  |  |  |  |  |  |  |  |  |  |  |  |  |  |  |  |  |  |  |  |  |  |  |  |  |  |  |  |  |  |  |
| 16331000M |  | H-D Complex P- I Begin Constr | milestone | 0d | 2009-02-02 | 2009-02-02 | 9-090M FS+79d | 62d | 0d |  |  | YASKY R | 1 | 1 | 6 | REBECCA Y |  |  |  |  | 3 | D | CVL | 08-023 | 09-010 | 09-007 | 10-042 | 10-061 |  |  |  |  |  |  |  |  |  |  |  |  |  |  |  |  |  |
| 16331005 |  | H-D Complex P- I Award Contract (BONDS) |  | 1d | 2009-02-02 | 2009-02-02 | 1243050b, 1243050, 1243055, 16331000M, 1243045 | 62d | 0d | PROCUREMENT<$50K 60; PROCUREMENT>$50K 69 | 125,000 | YASKY R | 1 | 1 |  | REBECCA Y |  |  |  | 631B | 3 |  | CVL | 08-023 | 09-010 | 09-007 | 10-042 | 10-061 | 08-017 | 09-012 |  |  |  |  |  |  |  |  |  |  |  |  |  |  |  |
| 16331010 |  | H-D Complex P- I Constrctn Contract Progress August 09 |  | 147d | 2009-02-03 | 2009-08-31 | 3C-03M, 16331005, 9-090M FS+80d | 253d | 163d | PROCUREMENT>$50K 69; PROCUREMENT<$50K 60 | 987,758.73 | YASKY R | 1 | 1 |  | REBECCA Y |  |  | APP | 631B |  |  |  | 08-023 | 09-010 | 09-007 | 10-042 | 10-061 |  | 09-012 | 07-024 | 08-014 | 08-016 | 08-055 | 09-010A | 09-038 | 09-044 | 10-051 |  |  |  |  |  |  |  |
| 16331010A |  | H-D Complex P- I Constrctn Contract Progress September 09 |  | 168d | 2009-02-03 | 2009-09-30 | 9-090M FS+80d | 232d | 142d | PROCUREMENT>$50K 69 | 216,955 | YASKY R | 1 | 1 |  | REBECCA Y |  |  | APP | 631B |  |  |  |  |  |  | 10-042 | 10-061 |  |  |  |  |  |  |  |  | 09-044 | 10-051 |  |  |  |  |  |  |  |
| 16331010B |  | H-D Complex P- I Constrctn Contract Progress October 09 |  | 190d | 2009-02-03 | 2009-10-30 | 9-090M FS+80d | 210d | 120d | PROCUREMENT>$50K 69 NO ESCALATION | 300,399.8 | YASKY R | 1 | 1 |  | REBECCA Y |  |  | APP | 631B |  |  |  |  |  |  | 10-042 | 10-061 |  |  |  |  |  |  |  |  | 09-044 | 10-051 | 10-001A |  |  |  |  |  |  |
| 16331010C |  | H-D Complex P- I Constrctn Contract Progress November 09 |  | 209d | 2009-02-03 | 2009-11-30 | 9-090M FS+80d | 191d | 101d | PROCUREMENT>$50K 69 NO ESCALATION | 508,966.2 | YASKY R | 1 | 1 |  | REBECCA Y |  |  | APP | 631B |  |  |  |  |  |  | 10-042 | 10-061 |  |  |  |  |  |  |  |  | 09-044 | 10-051 | 10-001A |  |  |  |  |  |  |
| 16331010D |  | H-D Complex P- I Constrctn Contract Progress December 09 |  | 226d | 2009-02-03 | 2009-12-30 | 9-090M FS+80d | 174d | 84d | PROCUREMENT>$50K 69 NO ESCALATION | 799,325.41 | YASKY R | 1 | 1 |  | REBECCA Y |  |  | APP | 631B |  |  |  |  |  |  | 10-042 | 10-061 |  |  |  |  |  |  |  |  | 09-044 | 10-051 | 10-001A |  |  |  |  |  |  |
| 16331010F |  | H-D Complex P- I Constrctn Contract Progress January 10 |  | 246d | 2009-02-03 | 2010-01-29 | 9-090M FS+80d | 154d | 64d | PROCUREMENT>$50K 69 NO ESCALATION | 633,143.25 | YASKY R | 1 | 1 |  | REBECCA Y |  |  | APP | 631B |  |  |  |  |  |  | 10-042 | 10-061 |  |  |  |  |  |  |  |  | 09-044 | 10-051 | 10-001A |  |  |  |  |  |  |
| 16331010G |  | H-D Complex P- I Constrctn Contract Progress February 10 |  | 265d | 2009-02-03 | 2010-02-26 | 9-090M FS+80d | 135d | 45d | PROCUREMENT>$50K 69 NO ESCALATION | 229,811 | YASKY R | 1 | 1 |  | REBECCA Y |  |  | APP | 631B |  |  |  |  |  |  | 10-042 | 10-061 |  |  |  |  |  |  |  |  | 09-044 | 10-051 | 10-001A |  |  |  |  |  |  |
| 16331010H |  | H-D Complex P- I Constrctn Contract Progress March 10 |  | 288d | 2009-02-03 | 2010-03-31 | 9-090M FS+80d | 112d | 22d | PROCUREMENT>$50K 69 NO ESCALATION | 393,348 | YASKY R | 1 | 1 |  | REBECCA Y |  |  | APP | 631B |  |  |  |  |  |  | 10-042 | 10-061 |  |  |  |  |  |  |  |  | 09-044 | 10-051 | 10-001A |  |  |  |  |  |  |
| 16331010J |  | H-D Complex P- I Constrctn Contract Progress April 10 |  | 310d | 2009-02-03 | 2010-04-30 | 9-090M FS+80d | 90d | 0d | PROCUREMENT>$50K 69 NO ESCALATION | 567,231 | YASKY R | 1 | 1 |  | REBECCA Y |  |  | APP | 631B |  |  |  |  |  |  | 10-042 | 10-061 |  |  |  |  |  |  |  |  | 09-044 | 10-051 | 10-001A |  |  |  |  |  |  |
| 16331010K |  | H-D Complex P- I Constrctn Contract Progress May 10 |  | 330d | 2009-02-03 | 2010-05-28 | 9-090M FS+80d | 70d | 0d | PROCUREMENT>$50K 69 NO ESCALATION | 394,533.25 | YASKY R | 1 | 1 |  | REBECCA Y |  |  | APP | 631B |  |  |  |  |  |  | 10-042 | 10-061 |  |  |  |  |  |  |  |  | 09-044 | 10-051 | 10-001A |  |  |  |  |  |  |
| 16331010L |  | H-D Complex P- I Constrctn Contract Progress June 10 |  | 352d | 2009-02-03 | 2010-06-30 | 9-090M FS+80d | 48d | 0d | PROCUREMENT>$50K 69 NO ESCALATION | 595,761 | YASKY R | 1 | 1 |  | REBECCA Y |  |  | APP | 631B |  |  |  |  |  |  | 10-042 | 10-061 |  |  |  |  |  |  |  |  | 09-044 | 10-051 | 10-001A |  |  |  |  |  |  |
| 16331010N |  | H-D Complex P- I Constrctn Contract Progress July 10 Original |  | 352d | 2009-02-03 | 2010-06-30 | 9-090M FS+80d | 19d | 18d | PROCUREMENT>$50K 69 NO ESCALATION | 30,023.78 | YASKY R | 1 | 1 |  | REBECCA Y |  |  | APP | 631B |  |  |  |  |  |  | 10-042 | 10-061 |  |  |  |  |  |  |  |  | 09-044 | 10-051 | 10-001A |  |  |  |  |  |  |
| 16331010N5 |  | H-D Complex P- I Constrctn Contract Progress July 10 Revised Delivery per CR10-061 |  | 370d | 2009-02-03 | 2010-07-27 | 9-090M FS+80d | 1d | 0d | PROCUREMENT>$50K 69 NO ESCALATION | 277,719.93 | YASKY R | 1 | 1 |  | REBECCA Y |  |  | APP | 631B |  |  |  |  |  |  | 10-042 | 10-061 |  |  |  |  |  |  |  |  | 09-044 | 10-051 | 10-001A |  |  |  |  |  |  |
| 16331010P |  | H-D Complex P- I Constrctn Contract Progress August 10 |  | 395d | 2009-02-03 | 2010-08-31 | 16331010N FS-370d, 16331010N5 FS-370d | 1d | 0d | PROCUREMENT>$50K 69 NO ESCALATION | 277,719.93 | YASKY R | 1 | 1 |  | REBECCA Y |  |  | APP | 631B |  |  |  |  |  |  | 10-042 | 10-061 |  |  |  |  |  |  |  |  | 09-044 | 10-051 | 10-001A |  |  |  |  |  |  |
| 16331010Q |  | H-D Complex P- I Constrctn Contract Progress September 10 |  | 416d | 2009-02-03 | 2010-09-30 | 16331010P FS-395d | 1d | 0d | PROCUREMENT>$50K 69 NO ESCALATION | 277,719.93 | YASKY R | 1 | 1 |  | REBECCA Y |  |  | APP | 631B |  |  |  |  |  |  | 10-042 | 10-061 |  |  |  |  |  |  |  |  | 09-044 | 10-051 | 10-001A |  |  |  |  |  |  |
| 16331010R |  | H-D Complex P- I Constrctn Contract Progress October 10 |  | 437d | 2009-02-03 | 2010-10-29 | 16331010Q FS-416d | 1d | 0d | PROCUREMENT>$50K 69 NO ESCALATION | 277,719.93 | YASKY R | 1 | 1 |  | REBECCA Y |  |  | APP | 631B |  |  |  |  |  |  | 10-042 | 10-061 |  |  |  |  |  |  |  |  | 09-044 | 10-051 | 10-001A |  |  |  |  |  |  |
| 16331010S |  | H-D Complex P- I Constrctn Contract Progress November 10 |  | 455d | 2009-02-03 | 2010-11-24 | 16331010R FS-437d | 1d | 0d | PROCUREMENT>$50K 69 NO ESCALATION | 277,719.93 | YASKY R | 1 | 1 |  | REBECCA Y |  |  | APP | 631B |  |  |  |  |  |  | 10-042 | 10-061 |  |  |  |  |  |  |  |  | 09-044 | 10-051 | 10-001A |  |  |  |  |  |  |
| 16331011 |  | H-D Complex P- I Constrctn Contract Modifications |  | 370d | 2009-02-03 | 2010-07-27 | 16331005 | 90d | 0d | PROCUREMENT>$50K 69 NO ESCALATION; PROCUREMENT>$50K 69; PROCUREMENT>$50K 69 NO ESCALATION FY10 | 354,138.36 | YASKY R | 1 | 1 |  | REBECCA Y |  |  | APP | 631B |  |  |  | 08-023 | 09-010 | 09-007 | 10-042 |  |  |  | 07-024 | 08-014 | 08-016 | 08-055 | 09-010A |  | 09-044 | 10-051 |  |  |  |  |  |  |  |
| 16331020 |  | H-D Complex P- I Constrctn Mngmnt Labor FY09 |  | 168d | 2009-02-03 | 2009-09-30 | 16331005 | 1402d | 0d | OFFICE [65.03 h]; MECH TECH [541.94 h]; ELEC ENG [43.35 h]; MECH ENG [21.68 h]; MECH DES [43.35 h]; PLANT ENG [173.42 h] | 40,765.92 | YASKY R | 1 | 1 |  | REBECCA Y |  |  | APP | 631A |  |  |  |  | 09-010 | 09-007 |  |  |  | 09-012 |  |  | 08-016 |  |  |  |  |  | 10-001B | 07-029 | 09-011 | 12-015 |  |  |  |
| 16331020c |  | H-D Complex P- I Constrctn Mngmnt Procurement |  | 310d | 2009-02-03 | 2010-04-30 | 16331005 | 1402d | 145d | PROCUREMENT<$50K 60 NO ESCALATION; PROCUREMENT>$50K 69 NO ESCALATION | 502,815 | YASKY R | 1 | 1 |  | REBECCA Y |  |  | APP | 631A |  |  |  |  |  |  |  |  |  |  |  |  |  |  |  |  |  |  | 10-001B |  |  | 12-015 |  |  |  |
| 16331025 |  | H-D Complex P- I A-E Constrctn Supprt |  | 310d | 2009-02-03 | 2010-04-30 | 16331005 | 1402d | 145d | PROCUREMENT<$50K 60 NO ESCALATION | 100,907.44 | YASKY R | 1 | 1 |  | REBECCA Y |  |  | APP | 631B |  |  |  |  | 09-010 | 09-007 |  |  |  | 09-012 |  |  | 08-016 |  |  |  |  |  | 10-001A |  |  | 12-015 | 08-034 |  |  |
| 16331012 |  | H-D Complex P- I ARRA Funds |  | 241d | 2009-08-06 | 2010-07-27 | 9-090M FS+209d | 1342d | 85d | PROCUREMENT>$50K 69 NO ESCALATION | 37,490.52 | YASKY R | 1 | 1 |  | REBECCA Y |  |  | APP | 631B |  |  |  |  |  |  |  |  |  |  |  |  |  |  |  |  | 09-044 |  |  |  |  | 12-015 |  |  |  |
| 16331020b |  | H-D Complex P- I Constrctn Mngmnt Labor FY10 |  | 142d | 2009-10-01 | 2010-04-30 | 16331020 | 1402d | 145d | ELEC ENG [36.65 h]; MECH ENG [18.32 h]; MECH DES [36.65 h]; PLANT ENG [146.58 h]; MECH TECH [458.06 h]; OFFICE [54.97 h] | 35,556.27 | YASKY R | 1 | 1 |  | REBECCA Y |  |  | APP | 631A |  |  |  |  |  |  |  |  |  |  |  |  |  |  |  |  |  |  | 10-001B |  |  | 12-015 |  |  |  |
| 16331013 |  | H-D Complex P- I Floor Slab Contract Modification |  | 22d | 2010-04-01 | 2010-04-30 | 9-100M FS+120d | 90d | 0d | PROCUREMENT>$50K 69 NO ESCALATION; PROCUREMENT<$50K 60 | 400,000 | YASKY R | 1 | 1 |  | REBECCA Y |  |  | APP | 631B |  |  |  |  | 09-010 | 09-007 | 10-042 | 10-061 |  |  |  |  |  |  |  |  |  | 10-051 | 10-001A |  |  |  |  |  |  |
| 16331015 |  | H-D Complex P- I Cmmssng Original |  | 40d | 2010-05-03 | 2010-06-28 | 16331011 FS-60d, 16331010G, 16331010L FS-42d, 16331010A, 16331010K FS-20d, 16331010N FS-60d, 16331010D, 16331010C, 16331010H, 16331010B, 16331013, 16331010F, 16331010J, 16331010 | 90d | 4d | PROCUREMENT<$50K 60 NO ESCALATION | 23,074.6 | YASKY R | 1 | 1 |  | REBECCA Y |  |  | APP | 631B |  |  |  |  | 09-010 | 09-007 | 10-042 | 10-061 |  |  |  |  |  |  |  |  |  | 10-051 | 10-001A |  |  |  |  |  |  |
| 16331030 |  | H-D Complex P- I Beneficial Occupancy Original |  | 2d | 2010-06-29 | 2010-06-30 | 16331010N FS-22d, 16331010N5 FS-22d, 16331010G, 16331010L FS-2d, 16331010B, 16331010H, 16331010J, 16331010D, 16331010K, 16331015 FS-4d, 16331010A, 16331010F, 16331010, 16331010C | 104d | 103d | PLANT ENG [4 h] | 263.88 | YASKY R | 1 | 1 |  | REBECCA Y |  |  |  |  | 3 |  | CVL | 08-023 | 09-010 | 09-007 | 10-042 | 10-061 |  |  |  |  |  |  |  |  |  | 10-051 |  |  |  |  |  |  |  |
| 16331014 |  | H-D Complex P- I Settlement Agreement and Release |  | 21d | 2010-07-01 | 2010-07-30 | 9-100M FS+184d | 27d | 22d | PROCUREMENT>$50K 69 NO ESCALATION; PROCUREMENT<$50K 60 | 885,000 | YASKY R | 1 | 1 |  | REBECCA Y |  |  | APP | 631B |  |  |  |  | 09-010 | 09-007 | 10-042 | 10-061 |  |  |  |  |  |  |  |  |  | 10-051 | 10-001A |  |  |  |  |  |  |
| 16331017 |  | Reverse Entry Per CR10-061 |  | 1d | 2010-07-01 | 2010-07-01 | 9-100M FS+184d | 63d |  | PROCUREMENT<$50K 60 NO ESCALATION; PROCUREMENT>$50K 69 NO ESCALATION; PLANT ENG [-4 h] | -53,362.26 | YASKY R | 1 | 1 |  | REBECCA Y |  |  | APP | 631B |  |  |  |  | 09-010 | 09-007 | 10-042 | 10-061 |  |  |  |  |  |  |  |  |  | 10-051 | 10-001A |  |  |  |  |  |  |
| 16331016 |  | H-D Complex P- I Cmmssng Revised Date per CR10-061 |  | 40d | 2010-09-01 | 2010-10-27 | 16331013, 16331010F, 16331011 FS-60d, 16331010D, 16331010K, 16331010A, 16331014, 16331010, 16331010G, 16331010H, 16331010R FS-42d, 16331010B, 16331010J, 16331010L, 16331010C | 5d | 4d | PROCUREMENT<$50K 60 NO ESCALATION | 23,074.6 | YASKY R | 1 | 1 |  | REBECCA Y |  |  | APP | 631B |  |  |  |  | 09-010 | 09-007 | 10-042 | 10-061 |  |  |  |  |  |  |  |  |  | 10-051 | 10-001A |  |  |  |  |  |  |
| 16331032 |  | H-D Complex P- I Beneficial Occupancy Revised Date per CR10-061 |  | 20d | 2010-10-28 | 2010-11-24 | 16331010, 16331010J, 16331010S FS-20d, 16331010K, 16331010L FS-2d, 16331010C, 16331010B, 16331010A, 16331010G, 16331016 FS-4d, 16331010F, 16331010H, 16331010R FS-10d, 16331015 FS-4d, 16331010D | 1d | 0d | PLANT ENG [40 h] | 2,722.8 | YASKY R | 1 | 1 |  | REBECCA Y |  |  |  |  | 3 |  | CVL | 08-023 | 09-010 | 09-007 | 10-042 | 10-061 |  |  |  |  |  |  |  |  |  | 10-051 |  |  |  |  |  |  |  |
| 16331035M |  | H-D Complex P- I Constr Comp | milestone | 0d | 2010-11-24 | 2010-11-24 | 3C-06M, 16331030, 16331025, 16331032, 16331020c, 16331020b, 16331012 | 1257d | 1201d |  |  | YASKY R | 1 | 1 | 6 | REBECCA Y |  |  |  |  |  | D |  |  | 09-010 | 09-007 |  | 10-061 |  |  |  |  |  |  |  |  |  |  |  |  |  | 12-015 |  |  |  |
| 16331040 |  | Re-Baseline Actuals Adjustment |  | 1d | 2013-08-30 | 2013-08-30 | 9-130M FS+227d | 20d |  | PROCUREMENT>$50K 69 NO ESCALATION | 66,963.44 | YASKY R | 1 | 1 |  | REBECCA Y |  |  |  |  |  |  |  |  |  |  |  |  |  |  |  |  |  |  |  |  |  |  |  |  |  |  |  | 13-014 | ADJ |

Notes:
- 16223000M: Entry Criteria: Predecessor 1242040M (CHL Design / Completed)

| ID | WBS | Activity | Type | Duration | Start | Finish | Predecessors | Total float | Free float | Resources | Cost | RESP - Responsibility | STRT%COMP for CM EVM | FNSH%COMP for CM EVM | 12 GeV 2nd level Critical Path | CIVIL CRITICAL MILESTONES | CR 08-017 | CR 08-023 | CAM RESPONSIBLE | CR 09-007 | CR 09-012 | CR 09-044 | CR 10-059 | CR 11-004 | CR 11-044 | Advance Purchase Plan > 500K | CR 08-014 | CR 08-016 | CR 09-010 | 12 GEV MAJOR PROCUREMENT CATAGORY | CR 10-001 | Milestone Level | HALL D Related Milestones | CR 11-020 | CR 07-029 | CR 09-011 | CR 11-001 | CR 12-015 | CR 08-034 | CR 10-028 | CR 12-029 | CR 08-056 | CR 10-019 | CR 11-026 | CR 11-047 | CR 12-009 | CR 13-014 | ReBaseline Actuals Adjustment |
| --- | --- | --- | --- | --- | --- | --- | --- | --- | --- | --- | --- | --- | --- | --- | --- | --- | --- | --- | --- | --- | --- | --- | --- | --- | --- | --- | --- | --- | --- | --- | --- | --- | --- | --- | --- | --- | --- | --- | --- | --- | --- | --- | --- | --- | --- | --- | --- | --- |
|  | 2 | **1.6.3.3.2 PHASE 2** |  |  | 2009-08-06 | 2013-08-30 |  |  |  |  |  |  |  |  |  |  |  |  |  |  |  |  |  |  |  |  |  |  |  |  |  |  |  |  |  |  |  |  |  |  |  |  |  |  |  |  |  |  |
| 16332005 |  | H-D Complex P- II Award Contract |  | 1d | 2009-08-06 | 2009-08-06 | 9-090M FS+209d | 6d | 0d |  |  | YASKY R | 1 | 1 | 2 | CVL | 08-017 | 08-023 | REBECCA Y | 09-007 | 09-012 | 09-044 | 10-059 | 11-004 | 11-044 |  |  |  |  |  |  |  |  |  |  |  |  |  |  |  |  |  |  |  |  |  |  |  |
| 16332010 |  | H-D Complex P- II Contract Progress June 2010 Progress Payment |  | 223d | 2009-08-06 | 2010-06-30 | 16332005 FS-1d | 6d | 0d | PROCUREMENT<$50K 60 NO ESCALATION; PROCUREMENT>$50K 69 NO ESCALATION | 301,352.5 | YASKY R | 1 | 1 |  |  |  |  | REBECCA Y | 09-007 | 09-012 | 09-044 | 10-059 | 11-004 | 11-044 | APP | 08-014 | 08-016 | 09-010 | 631B | 10-001A |  |  |  |  |  |  |  |  |  |  |  |  |  |  |  |  |  |
| 16332010B |  | H-D Complex P- II Contract Progress July 2010 Progress Payment |  | 244d | 2009-08-06 | 2010-07-30 | 16332010 FS-223d | 6d | 0d | PROCUREMENT>$50K 69 NO ESCALATION | 267,310 | YASKY R | 1 | 1 |  |  |  |  | REBECCA Y |  |  |  | 10-059 | 11-004 | 11-044 | APP |  |  |  | 631B |  |  |  |  |  |  |  |  |  |  |  |  |  |  |  |  |  |  |
| 16332010C |  | H-D Complex P- II Contract Progress August 2010 Progress Payment |  | 266d | 2009-08-06 | 2010-08-31 | 16332010B FS-244d | 6d | 0d | PROCUREMENT>$50K 69 NO ESCALATION | 64,389 | YASKY R | 1 | 1 |  |  |  |  | REBECCA Y |  |  |  | 10-059 | 11-004 | 11-044 | APP |  |  |  | 631B |  |  |  |  |  |  |  |  |  |  |  |  |  |  |  |  |  |  |
| 16332010D |  | H-D Complex P- II Contract Progress September 2010 Progress Payment |  | 287d | 2009-08-06 | 2010-09-30 | 16332010C FS-266d | 6d | 0d | PROCUREMENT>$50K 69 NO ESCALATION | 98,161 | YASKY R | 1 | 1 |  |  |  |  | REBECCA Y |  |  |  | 10-059 | 11-004 | 11-044 | APP |  |  |  | 631B |  |  |  |  |  |  |  |  |  |  |  |  |  |  |  |  |  |  |
| 16332010F |  | H-D Complex P- II Contract Progress October 2010 Progress Payment |  | 308d | 2009-08-06 | 2010-10-29 | 16332010D FS-287d | 6d | 0d | PROCUREMENT>$50K 69 NO ESCALATION | 227,000 | YASKY R | 1 | 1 |  |  |  |  | REBECCA Y |  |  |  | 10-059 | 11-004 | 11-044 | APP |  |  |  | 631B |  |  |  |  |  |  |  |  |  |  |  |  |  |  |  |  |  |  |
| 16332010G |  | H-D Complex P- II Contract Progress November 2010 Progress Payment |  | 328d | 2009-08-06 | 2010-11-30 | 16332010F FS-308d | 6d | 0d | PROCUREMENT>$50K 69 NO ESCALATION | 291,875 | YASKY R | 1 | 1 |  |  |  |  | REBECCA Y |  |  |  | 10-059 | 11-004 | 11-044 | APP |  |  |  | 631B |  |  |  |  |  |  |  |  |  |  |  |  |  |  |  |  |  |  |
| 16332010H |  | H-D Complex P- II Contract Progress December 2010 Progress Payment |  | 345d | 2009-08-06 | 2010-12-30 | 16332010G FS-328d | 6d | 0d | PROCUREMENT>$50K 69 NO ESCALATION | 289,502 | YASKY R | 1 | 1 |  |  |  |  | REBECCA Y |  |  |  | 10-059 | 11-004 | 11-044 | APP |  |  |  | 631B |  |  |  |  |  |  |  |  |  |  |  |  |  |  |  |  |  |  |
| 16332010J |  | H-D Complex P- II Contract Progress January 2011 Progress Payment |  | 365d | 2009-08-06 | 2011-01-31 | 16332010H FS-345d | 6d | 0d | PROCUREMENT>$50K 69 NO ESCALATION | 127,700 | YASKY R | 1 | 1 |  |  |  |  | REBECCA Y |  |  |  | 10-059 | 11-004 | 11-044 | APP |  |  |  | 631B |  |  |  |  |  |  |  |  |  |  |  |  |  |  |  |  |  |  |
| 16332010K |  | H-D Complex P- II Contract Progress February 2011 Progress Payment |  | 384d | 2009-08-06 | 2011-02-28 | 16332010J FS-365d | 6d | 0d | PROCUREMENT>$50K 69 NO ESCALATION | 192,348 | YASKY R | 1 | 1 |  |  |  |  | REBECCA Y |  |  |  | 10-059 | 11-004 | 11-044 | APP |  |  |  | 631B |  |  |  |  |  |  |  |  |  |  |  |  |  |  |  |  |  |  |
| 16332010N |  | H-D Complex P- II Contract Progress March 2011 Progress Payment |  | 407d | 2009-08-06 | 2011-03-31 | 16332010K FS-384d | 6d | 0d | PROCUREMENT>$50K 69 NO ESCALATION | 195,771 | YASKY R | 1 | 1 |  |  |  |  | REBECCA Y |  |  |  | 10-059 | 11-004 | 11-044 | APP |  |  |  | 631B |  |  |  |  |  |  |  |  |  |  |  |  |  |  |  |  |  |  |
| 16332010P |  | H-D Complex P- II Contract Progress April 2011 Progress Payment |  | 428d | 2009-08-06 | 2011-04-29 | 16332010N FS-407d | 6d | 0d | PROCUREMENT>$50K 69 NO ESCALATION | 206,551 | YASKY R | 1 | 1 |  |  |  |  | REBECCA Y |  |  |  | 10-059 | 11-004 | 11-044 | APP |  |  |  | 631B |  |  |  |  |  |  |  |  |  |  |  |  |  |  |  |  |  |  |
| 16332010Q |  | H-D Complex P- II Contract Progress May 2011 Progress Payment |  | 449d | 2009-08-06 | 2011-05-31 | 16332010P FS-428d | 6d | 0d | PROCUREMENT>$50K 69 NO ESCALATION | 800,206 | YASKY R | 1 | 1 |  |  |  |  | REBECCA Y |  |  |  | 10-059 | 11-004 | 11-044 | APP |  |  |  | 631B |  |  |  |  |  |  |  |  |  |  |  |  |  |  |  |  |  |  |
| 16332010R |  | H-D Complex P- II Contract Progress June 2011 Progress Payment |  | 471d | 2009-08-06 | 2011-06-30 | 16332010Q FS-449d | 6d | 0d | PROCUREMENT>$50K 69 NO ESCALATION | 199,024 | YASKY R | 1 | 1 |  |  |  |  | REBECCA Y |  |  |  | 10-059 | 11-004 | 11-044 | APP |  |  |  | 631B |  |  |  |  |  |  |  |  |  |  |  |  |  |  |  |  |  |  |
| 16332010S |  | H-D Complex P- II Contract Progress July 2011 Progress Payment |  | 491d | 2009-08-06 | 2011-07-29 | 16332010R FS-471d | 6d | 0d | PROCUREMENT>$50K 69 NO ESCALATION | 734,054 | YASKY R | 1 | 1 |  |  |  |  | REBECCA Y |  |  |  | 10-059 | 11-004 | 11-044 | APP |  |  |  | 631B |  |  |  |  |  |  |  |  |  |  |  |  |  |  |  |  |  |  |
| 16332010T |  | H-D Complex P- II Contract Progress August 2011 Progress Payment |  | 514d | 2009-08-06 | 2011-08-31 | 16332010S FS-491d | 6d | 0d | PROCUREMENT>$50K 69 NO ESCALATION | 734,054 | YASKY R | 1 | 1 |  |  |  |  | REBECCA Y |  |  |  | 10-059 | 11-004 | 11-044 | APP |  |  |  | 631B |  |  |  |  |  |  |  |  |  |  |  |  |  |  |  |  |  |  |
| 16332010U |  | H-D Complex P- II Contract Progress September 2011 Progress Payment |  | 535d | 2009-08-06 | 2011-09-30 | 16332010T FS-514d | 6d | 0d | PROCUREMENT>$50K 69 NO ESCALATION | 734,054 | YASKY R | 1 | 1 |  |  |  |  | REBECCA Y |  |  |  | 10-059 | 11-004 | 11-044 | APP |  |  |  | 631B |  |  |  |  |  |  |  |  |  |  |  |  |  |  |  |  |  |  |
| 16332010V |  | H-D Complex P- II Contract Progress October 2011 Progress Payment |  | 556d | 2009-08-06 | 2011-10-31 | 16332010U FS-535d | 6d | 0d | PROCUREMENT>$50K 69 NO ESCALATION | 734,054.75 | YASKY R | 1 | 1 |  |  |  |  | REBECCA Y |  |  |  | 10-059 | 11-004 | 11-044 | APP |  |  |  | 631B |  |  |  |  |  |  |  |  |  |  |  |  |  |  |  |  |  |  |
| 16332000M |  | H-D Complex P- II Begin Constr | milestone | 0d | 2010-01-05 | 2010-01-05 | 9-100M FS+60d | 87d | 0d |  |  | YASKY R | 1 | 1 | 2 | CVL |  | 08-023 | REBECCA Y | 09-007 |  |  | 10-059 |  |  |  |  |  |  |  |  | 6 | D | 11-020 |  |  |  |  |  |  |  |  |  |  |  |  |  |  |
| 16332008 |  | H-D Complex P- II Notice to Proceed |  | 20d | 2010-01-05 | 2010-02-02 | 16332000M | 87d | 0d |  |  | YASKY R | 1 | 1 | 2 | CVL |  |  | REBECCA Y |  |  | 09-044 | 10-059 |  |  |  |  |  |  |  |  |  |  |  |  |  |  |  |  |  |  |  |  |  |  |  |  |  |
| 16332011 |  | H-D Complex & Cryo Plant P- II Contract Modifications |  | 300d | 2010-02-03 | 2011-04-18 | 16332008 | 97d | 76d | PROCUREMENT>$50K 69 NO ESCALATION | 310,715.82 | YASKY R | 1 | 1 |  |  |  |  | REBECCA Y | 09-007 |  |  |  | 11-004 |  | APP | 08-014 | 08-016 | 09-010 | 631B | 10-001A |  |  |  |  |  |  |  |  |  |  |  |  |  |  |  |  |  |
| 16332012 |  | H-D Complex P- II ARRA Funds |  | 300d | 2010-02-03 | 2011-04-18 | 16332008 | 97d | 76d | PROCUREMENT<$50K 60 NO ESCALATION | 64,312.3 | YASKY R | 1 | 1 |  |  |  |  | REBECCA Y |  |  | 09-044 |  | 11-004 |  | APP |  |  |  | 631B | 10-001A |  |  |  |  |  |  |  |  |  |  |  |  |  |  |  |  |  |
| 16332020 |  | H-D Complex P- II Constrctn Mngmnt Labor FY10 |  | 168d | 2010-02-03 | 2010-09-30 | 16332008 | 1084d | 0d | MECH TECH [442.11 h]; MECH DES [123.79 h]; PLANT ENG [194.53 h]; OFFICE [88.42 h]; ELEC ENG [53.05 h]; MECH ENG [123.79 h] | 50,924.8 | YASKY R | 1 | 1 |  |  |  |  | REBECCA Y | 09-007 | 09-012 |  |  |  |  | APP |  | 08-016 |  | 631A | 10-001A |  |  |  | 07-029 | 09-011 | 11-001 | 12-015 |  |  |  |  |  |  |  |  |  |  |
| 16332020ba |  | H-D Complex P- II Constrctn Mngmnt Procurement |  | 380d | 2010-02-03 | 2011-08-10 | 16332008 | 1084d | 77d | PROCUREMENT<$50K 60 NO ESCALATION; PROCUREMENT>$50K 69 NO ESCALATION | 718,035.23 | YASKY R | 1 | 1 |  |  |  |  | REBECCA Y | 09-007 | 09-012 |  |  |  |  | APP |  | 08-016 |  | 631A | 10-001A |  |  |  | 07-029 | 09-011 | 11-001 | 12-015 |  |  |  |  |  |  |  |  |  |  |
| 16332025 |  | H-D Complex P- II A-E Constrctn Supprt |  | 380d | 2010-02-03 | 2011-08-10 | 16332008 | 1084d | 77d | PROCUREMENT<$50K 60 NO ESCALATION FY11 | 163,225.89 | YASKY R | 1 | 1 |  |  |  |  | REBECCA Y | 09-007 | 09-012 |  |  |  |  | APP |  | 08-016 |  | 631B |  |  |  |  |  |  |  |  | 08-034 | 10-028 | 12-029F |  |  |  |  |  |  |  |
| 16332040 |  | H-D Complex Cryo Plant P- II Contract Progress September 2010 Progress Payment |  | 168d | 2010-02-03 | 2010-09-30 | 16332008 | 87d | 0d | PROCUREMENT>$50K 69 NO ESCALATION | 14,625 | YASKY R | 1 | 1 |  |  |  |  | REBECCA Y | 09-007 | 09-012 |  | 10-059 |  |  |  | 08-014 | 08-016 | 09-010 | 631B | 10-001A |  |  |  |  |  |  |  |  |  |  | 08-056 |  |  |  |  |  |  |
| 16332040A |  | H-D Complex Cryo Plant P- II Contract Progress October 2010 Progress Payment |  | 189d | 2010-02-03 | 2010-10-29 | 16332040 FS-168d | 87d | 0d | PROCUREMENT>$50K 69 NO ESCALATION | 20,740 | YASKY R | 1 | 1 |  |  |  |  | REBECCA Y |  |  |  | 10-059 |  |  |  |  |  |  | 631B |  |  |  | 11-020 |  |  |  |  |  |  |  |  |  |  |  |  |  |  |
| 16332040B |  | H-D Complex Cryo Plant P- II Contract Progress November 2010 Progress Payment |  | 209d | 2010-02-03 | 2010-11-30 | 16332040A FS-189d | 87d | 0d | PROCUREMENT>$50K 69 NO ESCALATION | 39,564 | YASKY R | 1 | 1 |  |  |  |  | REBECCA Y |  |  |  | 10-059 |  |  |  |  |  |  | 631B |  |  |  | 11-020 |  |  |  |  |  |  |  |  |  |  |  |  |  |  |
| 16332040C |  | H-D Complex Cryo Plant P- II Contract Progress December 2010 Progress Payment |  | 226d | 2010-02-03 | 2010-12-30 | 16332040B FS-209d | 87d | 0d | PROCUREMENT>$50K 69 NO ESCALATION | 9,095.68 | YASKY R | 1 | 1 |  |  |  |  | REBECCA Y |  |  |  | 10-059 |  |  |  |  |  |  | 631B |  |  |  | 11-020 |  |  |  |  |  |  |  |  |  |  |  |  |  |  |
| 16332040D |  | H-D Complex Cryo Plant P- II Contract Progress January 2011 Progress Payment |  | 246d | 2010-02-03 | 2011-01-31 | 16332040C FS-226d | 87d | 0d | PROCUREMENT>$50K 69 NO ESCALATION | 90,834 | YASKY R | 1 | 1 |  |  |  |  | REBECCA Y |  |  |  | 10-059 |  |  |  |  |  |  | 631B |  |  |  | 11-020 |  |  |  |  |  |  |  |  |  |  |  |  |  |  |
| 16332040F |  | H-D Complex Cryo Plant P- II Contract Progress February 2011 Progress Payment |  | 265d | 2010-02-03 | 2011-02-28 | 16332040D FS-246d | 87d | 0d | PROCUREMENT>$50K 69 NO ESCALATION | 40,288 | YASKY R | 1 | 1 |  |  |  |  | REBECCA Y |  |  |  | 10-059 |  |  |  |  |  |  | 631B |  |  |  | 11-020 |  |  |  |  |  |  |  |  |  |  |  |  |  |  |
| 16332010A |  | H-D Complex P- II Contract Progress 2010 ETC FY10 |  | 151d | 2010-03-01 | 2010-09-30 | 9-100M FS+97d | 97d | 0d | MECH TECH [384.17 h]; MECH ENG [42.69 h] | 18,846.4 | YASKY R | 1 | 1 |  |  |  |  | REBECCA Y |  |  |  |  | 11-004 |  | APP |  |  |  | 631B |  |  |  |  |  |  | 11-001 |  |  |  |  |  | 10-019 |  |  |  |  |  |
| 16332020A |  | H-D Complex P- II Constrctn Mngmnt 2010 ETC Labor FY11 |  | 151d | 2010-03-01 | 2010-09-30 | 9-100M FS+97d | 1084d | 0d | MECH TECH [332.78 h]; PLANT ENG [66.56 h]; ELEC ENG [33.28 h]; MECH ENG [166.39 h] | 31,443.45 | YASKY R | 1 | 1 |  |  |  |  | REBECCA Y |  |  |  |  |  |  | APP |  |  |  | 631A |  |  |  |  |  |  | 11-001 | 12-015 |  |  |  |  | 10-019 |  |  |  |  |  |
| 16332020Ab |  | H-D Complex P- II Constrctn Mngmnt 2010 ETC Procurement |  | 363d | 2010-03-01 | 2011-08-10 | 9-100M FS+97d | 1084d | 77d | PROCUREMENT>$50K 69 NO ESCALATION | 206,000 | YASKY R | 1 | 1 |  |  |  |  | REBECCA Y |  |  |  |  |  |  | APP |  |  |  | 631A |  |  |  |  |  |  | 11-001 | 12-015 |  |  |  |  | 10-019 |  |  |  |  |  |
| 16332010Ab |  | H-D Complex P- II Contract Progress 2010 ETC FY11 |  | 132d | 2010-10-01 | 2011-04-18 | 16332010A | 97d | 76d | MECH TECH [335.83 h]; MECH ENG [37.31 h] | 16,999.41 | YASKY R | 1 | 1 |  |  |  |  | REBECCA Y |  |  |  |  | 11-004 |  | APP |  |  |  | 631B |  |  |  |  |  |  | 11-001 |  |  |  |  |  | 10-019 |  |  |  |  |  |
| 16332020Aa |  | H-D Complex P- II Constrctn Mngmnt 2010 ETC Labor FY11 |  | 212d | 2010-10-01 | 2011-08-10 | 16332020A | 1084d | 77d | MECH ENG [233.61 h]; MECH TECH [467.22 h]; PLANT ENG [93.44 h]; ELEC ENG [46.72 h] | 45,552.14 | YASKY R | 1 | 1 |  |  |  |  | REBECCA Y |  |  |  |  |  |  | APP |  |  |  | 631A |  |  |  |  |  |  | 11-001 | 12-015 |  |  |  |  | 10-019 |  |  |  |  |  |
| 16332020b |  | H-D Complex P- II Constrctn Mngmnt Labor FY11 |  | 212d | 2010-10-01 | 2011-08-10 | 16332020 | 1084d | 77d | MECH TECH [557.89 h]; MECH DES [156.21 h]; PLANT ENG [245.47 h]; OFFICE [111.58 h]; ELEC ENG [66.95 h]; MECH ENG [156.21 h] | 66,309.27 | YASKY R | 1 | 1 |  |  |  |  | REBECCA Y | 09-007 | 09-012 |  |  |  |  | APP |  | 08-016 |  | 631A | 10-001A |  |  |  | 07-029 | 09-011 | 11-001 | 12-015 |  |  |  |  |  |  |  |  |  |  |
| 16332045 |  | H-D Elect Utilities Proc Telecomm Cable & Equip |  | 100d | 2011-03-16 | 2011-08-04 | 16332010 FS-80d, 16332010U FS-140d | 27d | 0d | SCIENTIST [160 h] | 10,948.8 | YASKY R | 1 | 1 |  |  |  |  | REBECCA Y | 09-007 |  |  | 10-059 |  |  |  |  |  |  |  |  |  |  |  |  |  |  |  |  |  |  |  |  |  |  |  |  |  |
| 16332015 |  | H-D Complex P- II Cmmssng |  | 40d | 2011-08-05 | 2011-09-30 | 16332010Ab, 16332011, 16332040F, 16332010U FS-40d, 16332040, 16332010, 16332012 | 21d | 0d | PROCUREMENT<$50K 60 | 96,376.11 | YASKY R | 1 | 1 |  |  |  |  | REBECCA Y | 09-007 |  |  | 10-059 | 11-004 |  | APP |  |  |  | 631B |  |  |  |  |  |  |  |  |  |  |  |  |  |  |  |  |  |  |
| 16332050 |  | H-D Elect Utilities Install Telecomm Cable & Equip |  | 40d | 2011-08-05 | 2011-09-30 | 16332010U FS-40d, 16332010, 16332045 | 27d | 21d | PROCUREMENT<$50K 60; PROCUREMENT>$50K 69 | 102,045.28 | YASKY R | 1 | 1 |  |  |  |  | REBECCA Y | 09-007 |  |  | 10-059 |  |  |  |  |  |  | 631B |  |  |  |  |  |  |  |  |  |  |  |  |  |  |  |  |  |  |
| 16332030 |  | H-D Complex P- II Beneficial Occupancy |  | 20d | 2011-11-01 | 2011-11-30 | 16332010U, 16332050, 16332010, 16332015, 16332010V | 6d | 0d | PLANT ENG [40 h] | 2,809.6 | YASKY R | 1 | 1 |  |  | 08-017 | 08-023 | REBECCA Y | 09-007 |  |  | 10-059 |  | 11-044 |  |  |  |  |  |  |  |  |  |  |  |  |  |  |  |  |  |  |  |  |  |  |  |
| 16332035 |  | H-D Complex P- II Constr Comp | milestone | 0d | 2011-11-30 | 2011-11-30 | 16332025, 16332020b, 16332020ba, 16332030, 16332020Ab, 16332020Aa, 16332010W FS-60d, 13455145, 13455135 | 1007d | 951d |  |  | YASKY R | 1 | 1 |  |  |  |  | REBECCA Y | 09-007 |  |  | 10-059 |  | 11-044 |  |  |  |  |  |  | 6 | D |  |  |  |  | 12-015 |  |  |  |  |  |  |  |  |  |  |
| 16332010W |  | H-D Complex P-II Contractor Claim #2 |  | 19d | 2012-01-04 | 2012-01-31 | 9-120M FS+59d | 1030d | 23d | PROCUREMENT>$50K 69 NO ESCALATION; PROCUREMENT<$50K 60 NO ESCALATION | 300,000 | YASKY R | 1 | 1 |  |  | 08-017 |  | REBECCA Y | 09-007 |  | 09-044 |  |  |  | APP | 08-014 |  | 09-010 | 631B | 10-001A |  |  |  |  |  |  | 12-015 |  |  |  |  |  | 11-026 | 11-047 | 12-009 |  |  |
| 16332055 |  | Re-Baseline Actuals Adjustment |  | 1d | 2013-08-30 | 2013-08-30 | 9-130M FS+227d | 20d |  | PROCUREMENT>$50K 69 NO ESCALATION | 364,195.36 | YASKY R | 1 | 1 |  |  |  |  | REBECCA Y |  |  |  |  |  |  |  |  |  |  |  |  |  |  |  |  |  |  |  |  |  |  |  |  |  |  |  | 13-014 | ADJ |

Notes:
- 16332010: Explanation: Phase 2 Totals are 16332010 Contract Progress and 16332040 Cryo Plant / Combined = $6,412,552.93 03 Sept 2009.
- 16332010B: Explanation: Phase 2 Totals are 16332010 Contract Progress and 16332040 Cryo Plant / Combined = $6,412,552.93 03 Sept 2009.
- 16332010C: Explanation: Phase 2 Totals are 16332010 Contract Progress and 16332040 Cryo Plant / Combined = $6,412,552.93 03 Sept 2009.
- 16332010D: Explanation: Phase 2 Totals are 16332010 Contract Progress and 16332040 Cryo Plant / Combined = $6,412,552.93 03 Sept 2009.
- 16332010F: Explanation: Phase 2 Totals are 16332010 Contract Progress and 16332040 Cryo Plant / Combined = $6,412,552.93 03 Sept 2009.
- 16332010G: Explanation: Phase 2 Totals are 16332010 Contract Progress and 16332040 Cryo Plant / Combined = $6,412,552.93 03 Sept 2009.
- 16332010H: Explanation: Phase 2 Totals are 16332010 Contract Progress and 16332040 Cryo Plant / Combined = $6,412,552.93 03 Sept 2009.
- 16332010J: Explanation: Phase 2 Totals are 16332010 Contract Progress and 16332040 Cryo Plant / Combined = $6,412,552.93 03 Sept 2009.
- 16332010K: Explanation: Phase 2 Totals are 16332010 Contract Progress and 16332040 Cryo Plant / Combined = $6,412,552.93 03 Sept 2009.
- 16332010N: Explanation: Phase 2 Totals are 16332010 Contract Progress and 16332040 Cryo Plant / Combined = $6,412,552.93 03 Sept 2009.
- 16332010P: Explanation: Phase 2 Totals are 16332010 Contract Progress and 16332040 Cryo Plant / Combined = $6,412,552.93 03 Sept 2009.
- 16332010Q: Explanation: Phase 2 Totals are 16332010 Contract Progress and 16332040 Cryo Plant / Combined = $6,412,552.93 03 Sept 2009.
- 16332010R: Explanation: Phase 2 Totals are 16332010 Contract Progress and 16332040 Cryo Plant / Combined = $6,412,552.93 03 Sept 2009.
- 16332010S: Explanation: Phase 2 Totals are 16332010 Contract Progress and 16332040 Cryo Plant / Combined = $6,412,552.93 03 Sept 2009.
- 16332010T: Explanation: Phase 2 Totals are 16332010 Contract Progress and 16332040 Cryo Plant / Combined = $6,412,552.93 03 Sept 2009.
- 16332010U: Explanation: Phase 2 Totals are 16332010 Contract Progress and 16332040 Cryo Plant / Combined = $6,412,552.93 03 Sept 2009.
- 16332010V: Explanation: Phase 2 Totals are 16332010 Contract Progress and 16332040 Cryo Plant / Combined = $6,412,552.93 03 Sept 2009.
- 16332020: Corrective Actions: Deleted FY12 funding as a / predecessor.
- 16332020ba: Corrective Actions: Deleted FY12 funding as a / predecessor.
- 16332040: Explanation: Phase 2 Totals are 16332010 Contract Progress and 16332040 Cryo Plant / Combined = $6,412,552.93 03 Sept 2009.
- 16332040A: Explanation: Phase 2 Totals are 16332010 Contract Progress and 16332040 Cryo Plant / Combined = $6,412,552.93 03 Sept 2009.
- 16332040B: Explanation: Phase 2 Totals are 16332010 Contract Progress and 16332040 Cryo Plant / Combined = $6,412,552.93 03 Sept 2009.
- 16332040C: Explanation: Phase 2 Totals are 16332010 Contract Progress and 16332040 Cryo Plant / Combined = $6,412,552.93 03 Sept 2009.
- 16332040D: Explanation: Phase 2 Totals are 16332010 Contract Progress and 16332040 Cryo Plant / Combined = $6,412,552.93 03 Sept 2009.
- 16332040F: Explanation: Phase 2 Totals are 16332010 Contract Progress and 16332040 Cryo Plant / Combined = $6,412,552.93 03 Sept 2009.
- 16332010A: Explanation: Phase 2 Totals are 16332010 Contract Progress and 16332040 Cryo Plant / Combined = $6,412,552.93 03 Sept 2009.
- 16332020A: Corrective Actions: Deleted FY12 funding as a / predecessor.
- 16332020Ab: Corrective Actions: Deleted FY12 funding as a / predecessor.
- 16332010Ab: Explanation: Phase 2 Totals are 16332010 Contract Progress and 16332040 Cryo Plant / Combined = $6,412,552.93 03 Sept 2009.
- 16332020Aa: Corrective Actions: Deleted FY12 funding as a / predecessor.
- 16332020b: Corrective Actions: Deleted FY12 funding as a / predecessor.

| ID | WBS | Activity | Type | Duration | Start | Finish | Predecessors | Total float | Free float | Calendar | Resources | Cost | RESP - Responsibility | STRT%COMP for CM EVM | FNSH%COMP for CM EVM | CR 08-017 | CAM RESPONSIBLE | CR 09-007 | CR 09-044 | CR 11-026 | CR 11-047 | CR 12-018 | Advance Purchase Plan > 500K | CR 08-014 | CR 09-010 | 12 GEV MAJOR PROCUREMENT CATAGORY | CR 10-001 | Milestone Level | HALL D Related Milestones | CR 10-030 | CR 07-029 | CR 08-023 | CR 09-011 | CR 09-012 | CR 10-019 | CR 12-015 | CR 08-034 | CR 08-016 | CR 12-009 | CR 13-014 | ReBaseline Actuals Adjustment | CR 08-058 | CR 10-037 | CR 10-050 | CR 11-007 | CR 12-038 | Original Activity ID Rebaseline | Over Under Fixed | BOE Labor | BOE Expenses | CR 13-015 | Post Rebaseline | Obligated Prior to Rebaseline | CR 14-001 |
| --- | --- | --- | --- | --- | --- | --- | --- | --- | --- | --- | --- | --- | --- | --- | --- | --- | --- | --- | --- | --- | --- | --- | --- | --- | --- | --- | --- | --- | --- | --- | --- | --- | --- | --- | --- | --- | --- | --- | --- | --- | --- | --- | --- | --- | --- | --- | --- | --- | --- | --- | --- | --- | --- | --- |
|  | 3 | **1.6.3.3.3 PHASE 3** |  |  | 2009-08-06 | 2013-08-30 |  |  |  |  |  |  |  |  |  |  |  |  |  |  |  |  |  |  |  |  |  |  |  |  |  |  |  |  |  |  |  |  |  |  |  |  |  |  |  |  |  |  |  |  |  |  |  |  |
| 16333005 |  | H-D Complex P- III Award Contract |  | 1d | 2009-08-06 | 2009-08-06 | 9-090M FS+209d | 184d | 0d |  |  |  | YASKY R | 1 | 1 | 08-017 | REBECCA Y | 09-007 | 09-044 | 11-026 | 11-047 | 12-018F |  |  |  |  |  |  |  |  |  |  |  |  |  |  |  |  |  |  |  |  |  |  |  |  |  |  |  |  |  |  |  |  |
| 16333010 |  | H-D Complex P- III Contract Progress June 2011 |  | 471d | 2009-08-06 | 2011-06-30 | 16333005 FS-1d | 184d | 0d |  | PROCUREMENT>$50K 69 NO ESCALATION; PROCUREMENT<$50K 60 NO ESCALATION | 123,073 | YASKY R | 1 | 1 | 08-017 | REBECCA Y | 09-007 | 09-044 | 11-026 | 11-047 | 12-018F | APP | 08-014 | 09-010 | 631B | 10-001A |  |  |  |  |  |  |  |  |  |  |  |  |  |  |  |  |  |  |  |  |  |  |  |  |  |  |  |
| 16333010A |  | H-D Complex P- III Contract Progress July 2011 |  | 491d | 2009-08-06 | 2011-07-29 | 16333010 FS-471d | 184d | 0d |  | PROCUREMENT>$50K 69 NO ESCALATION | 115,281.56 | YASKY R | 1 | 1 | 08-017 | REBECCA Y | 09-007 | 09-044 | 11-026 | 11-047 | 12-018F | APP | 08-014 | 09-010 | 631B | 10-001A |  |  |  |  |  |  |  |  |  |  |  |  |  |  |  |  |  |  |  |  |  |  |  |  |  |  |  |
| 16333010B |  | H-D Complex P- III Contract Progress August 2011 |  | 514d | 2009-08-06 | 2011-08-31 | 16333010A FS-491d | 184d | 0d |  | PROCUREMENT>$50K 69 NO ESCALATION | 115,735 | YASKY R | 1 | 1 | 08-017 | REBECCA Y | 09-007 | 09-044 | 11-026 | 11-047 | 12-018F | APP | 08-014 | 09-010 | 631B | 10-001A |  |  |  |  |  |  |  |  |  |  |  |  |  |  |  |  |  |  |  |  |  |  |  |  |  |  |  |
| 16333010C |  | H-D Complex P- III Contract Progress September 2011 |  | 535d | 2009-08-06 | 2011-09-30 | 16333010B FS-514d | 184d | 0d |  | PROCUREMENT>$50K 69 NO ESCALATION | 160,000 | YASKY R | 1 | 1 | 08-017 | REBECCA Y | 09-007 | 09-044 | 11-026 | 11-047 | 12-018F | APP | 08-014 | 09-010 | 631B | 10-001A |  |  |  |  |  |  |  |  |  |  |  |  |  |  |  |  |  |  |  |  |  |  |  |  |  |  |  |
| 16333010D |  | H-D Complex P- III Contract Progress October 2011 |  | 556d | 2009-08-06 | 2011-10-31 | 16333010C FS-535d | 184d | 1d |  | PROCUREMENT>$50K 69 NO ESCALATION | 155,301.66 | YASKY R | 1 | 1 | 08-017 | REBECCA Y | 09-007 | 09-044 | 11-026 | 11-047 | 12-018F | APP | 08-014 | 09-010 | 631B | 10-001A |  |  |  |  |  |  |  |  |  |  |  |  |  |  |  |  |  |  |  |  |  |  |  |  |  |  |  |
| 16333000M |  | H-D Complex P- III Begin Constr | milestone | 0d | 2011-01-05 | 2011-01-05 | 9-110M FS+60d | 232d | 0d |  |  |  | YASKY R | 1 | 1 |  | REBECCA Y | 09-007 |  | 11-026 |  | 12-018F |  |  |  |  |  | 6 | D |  |  |  |  |  |  |  |  |  |  |  |  |  |  |  |  |  |  |  |  |  |  |  |  |  |
| 16333008 |  | H-D Complex P- III Notice to Proceed |  | 1d | 2011-01-05 | 2011-01-05 | 16333000M | 232d | 49d |  |  |  | YASKY R | 1 | 1 |  | REBECCA Y |  | 09-044 | 11-026 | 11-047 | 12-018F |  |  |  |  |  |  |  |  |  |  |  |  |  |  |  |  |  |  |  |  |  |  |  |  |  |  |  |  |  |  |  |  |
| 16333011 |  | H-D Complex P- III Contract Modifications |  | 130d | 2011-03-18 | 2011-09-20 | 4A-01M FS-40d, 16333008 | 183d | 0d |  | PROCUREMENT>$50K 69 NO ESCALATION | 31,432.19 | YASKY R | 1 | 1 | 08-017 | REBECCA Y | 09-007 |  | 11-026 |  | 12-018F | APP | 08-014 | 09-010 | 631B | 10-001A |  |  | 10-030 |  |  |  |  |  |  |  |  |  |  |  |  |  |  |  |  |  |  |  |  |  |  |  |  |
| 16333012 |  | H-D Complex P- III ARRA Funds |  | 130d | 2011-03-18 | 2011-09-20 | 4A-01M FS-40d, 16333008 | 183d | 0d |  | PROCUREMENT>$50K 69 NO ESCALATION | 27,562.42 | YASKY R | 1 | 1 |  | REBECCA Y |  | 09-044 | 11-026 |  | 12-018F | APP |  |  | 631B | 10-001A |  |  | 10-030 |  |  |  |  |  |  |  |  |  |  |  |  |  |  |  |  |  |  |  |  |  |  |  |  |
| 16333020 |  | H-D Complex P- III Constrctn Mngmnt |  | 130d | 2011-03-18 | 2011-09-20 | 4A-01M FS-40d, 16333008 | 1056d | 30d |  | OFFICE [40 h]; MECH TECH [1080 h]; PLANT ENG [200 h]; PROCUREMENT>$50K 69 NO ESCALATION; ELEC ENG [40 h]; MECH ENG [200 h]; PROCUREMENT<$50K 60 NO ESCALATION; MECH DES [40 h] | 512,368.68 | YASKY R | 1 | 1 | 08-017 | REBECCA Y | 09-007 |  |  |  |  | APP |  |  | 631A | 10-001A |  |  | 10-030 | 07-029 | 08-023 | 09-011 | 09-012 | 10-019 | 12-015 |  |  |  |  |  |  |  |  |  |  |  |  |  |  |  |  |  |  |
| 16333025 |  | H-D Complex P- III A-E Constrctn Supprt |  | 130d | 2011-03-18 | 2011-09-20 | 16333008, 4A-01M FS-40d | 1056d | 30d |  | PROCUREMENT<$50K 60 | 14,520.45 | YASKY R | 1 | 1 | 08-017 | REBECCA Y | 09-007 |  |  |  |  | APP |  |  | 631B |  |  |  | 10-030 |  | 08-023 |  | 09-012 |  | 12-015 | 08-034 |  |  |  |  |  |  |  |  |  |  |  |  |  |  |  |  |  |
| 16333015 |  | H-D Complex P- III Cmmssng |  | 20d | 2011-09-21 | 2011-10-18 | 16333012, 16333011, 16333010D FS-30d | 183d | 0d |  | PROCUREMENT<$50K 60 NO ESCALATION FY12 | 5,850.59 | YASKY R | 1 | 1 |  | REBECCA Y | 09-007 |  | 11-026 | 11-047 | 12-018F | APP |  |  | 631B |  |  |  |  |  |  |  | 09-012 |  |  |  | 08-016 |  |  |  |  |  |  |  |  |  |  |  |  |  |  |  |  |
| 16333030 |  | H-D Complex P- III Beneficial Occupancy |  | 10d | 2011-10-19 | 2011-11-01 | 16333015, 16333011, 16333010D FS-556d | 183d | 0d |  | PLANT ENG [40 h] | 2,809.6 | YASKY R | 1 | 1 |  | REBECCA Y | 09-007 |  | 11-026 | 11-047 | 12-018F |  |  |  |  |  |  |  |  |  |  |  |  |  |  |  |  |  |  |  |  |  |  |  |  |  |  |  |  |  |  |  |  |
| 16333035 |  | H-D Complex P- III Constr Comp | milestone | 0d | 2011-11-01 | 2011-11-01 | 16333020, 16333030, 16333010F FS-60d, 16333025 | 1026d | 970d |  |  |  | YASKY R | 1 | 1 |  | REBECCA Y | 09-007 |  |  | 11-047 |  |  |  |  |  |  | 6 | D |  |  |  |  |  |  | 12-015 |  |  |  |  |  |  |  |  |  |  |  |  |  |  |  |  |  |  |
| 16333010F |  | H-D Complex P-III Contractor Claim #2 |  | 5d | 2011-12-01 | 2011-12-07 | 9-120M FS+41d | 1062d | 36d |  | PROCUREMENT>$50K 69 NO ESCALATION; PROCUREMENT<$50K 60 NO ESCALATION | 355,000 | YASKY R | 1 | 1 | 08-017 | REBECCA Y | 09-007 | 09-044 | 11-026 | 11-047 |  | APP | 08-014 | 09-010 | 631B | 10-001A |  |  |  |  |  |  |  |  | 12-015 |  |  | 12-009 |  |  |  |  |  |  |  |  |  |  |  |  |  |  |  |
| 16333040 |  | Re-Baseline Actuals Adjustment |  | 1d | 2013-08-30 | 2013-08-30 | 9-130M FS+227d | 20d |  |  | PROCUREMENT>$50K 69 NO ESCALATION | -30,133.8 | YASKY R | 1 | 1 |  | REBECCA Y |  |  |  |  |  |  |  |  |  |  |  |  |  |  |  |  |  |  |  |  |  |  | 13-014 | ADJ |  |  |  |  |  |  |  |  |  |  |  |  |  |
|  | 7 | **1.7 PROJECT MANAGEMENT** |  |  | 2008-10-01 | 2014-09-30 |  |  |  |  |  |  |  |  |  |  |  |  |  |  |  |  |  |  |  |  |  |  |  |  |  |  |  |  |  |  |  |  |  |  |  |  |  |  |  |  |  |  |  |  |  |  |  |  |
|  | 1 | **1.7.1 PROJECT OFFICE** |  |  | 2009-01-02 | 2014-09-30 |  |  |  |  |  |  |  |  |  |  |  |  |  |  |  |  |  |  |  |  |  |  |  |  |  |  |  |  |  |  |  |  |  |  |  |  |  |  |  |  |  |  |  |  |  |  |  |  |
| 171909LOE |  | FY09 Constrctn Proj Office Proj Mngmnt |  | 189d | 2009-01-02 | 2009-09-30 | 171909LOEX | 20d | 0d |  | ELEC ENG [2682.58 h]; SR STAFF [5365.16 h]; SCIENTIST [670.65 h]; ADMIN [1341.29 h]; OFFICE [1341.29 h]; SUPPLIES & MATERIALS; DIRECTORATE [548.71 h] | 1,061,187.37 | RODE C | 1 | 1 |  | CLAUS R |  |  |  |  |  |  |  |  |  |  |  |  |  |  |  |  |  |  |  |  |  |  |  |  | 08-058 |  |  |  |  |  |  |  |  |  |  |  |  |
| 171910LOE |  | FY10 Constrctn Proj Office Proj Mngmnt |  | 248d | 2009-10-01 | 2010-09-30 | 171909LOE | 20d | 0d |  | ADMIN [1760 h]; SR STAFF [7040 h]; SCIENTIST [880 h]; ELEC ENG [3520 h]; SUPPLIES & MATERIALS; DIRECTORATE [720 h]; OFFICE [1760 h] | 1,406,243.55 | RODE C | 1 | 1 |  | CLAUS R |  |  |  |  |  |  |  |  |  |  |  |  |  |  |  |  |  |  |  |  |  |  |  |  |  |  |  |  |  |  |  |  |  |  |  |  |  |
| 171910ALOE |  | FY10 Constrctn Proj Office Proj Mngmnt (Accelerator Work Coordinator) |  | 151d | 2010-03-01 | 2010-09-30 | 9-100M FS+97d | 20d | 0d |  | MECH ENG [1320 h] | 86,922 | RODE C | 1 | 1 |  | CLAUS R |  |  |  |  |  |  |  |  |  |  |  |  |  |  |  |  |  |  |  |  |  |  |  |  |  | 10-037 |  |  |  |  |  |  |  |  |  |  |  |
| 171910BLOE |  | FY10 Constrctn Proj Office Proj Mngmnt (CR 10-050) |  | 128d | 2010-04-01 | 2010-09-30 | 9-100M FS+120d | 20d | 0d |  | SUPPLIES & MATERIALS | 120,000 | RODE C | 1 | 1 |  | CLAUS R |  |  |  |  |  |  |  |  |  |  |  |  |  |  |  |  |  |  |  |  |  |  |  |  |  |  | 10-050 |  |  |  |  |  |  |  |  |  |  |
| 171911LOE |  | FY11 Constrctn Proj Office Proj Mngmnt |  | 248d | 2010-10-01 | 2011-09-30 | 171910BLOE, 171910ALOE, 171910LOE | 20d | 0d |  | ELEC ENG [3520 h]; SCIENTIST [880 h]; SR STAFF [5544 h]; MECH ENG [1760 h]; DIRECTORATE [2216 h]; ADMIN [1760 h]; SUPPLIES & MATERIALS; OFFICE [1760 h] | 1,818,372.05 | RODE C | 1 | 1 |  | CLAUS R |  |  |  |  |  |  |  |  |  |  |  |  |  |  |  |  |  |  |  |  |  |  |  |  |  | 10-037 | 10-050 | 11-007 |  |  |  |  |  |  |  |  |  |
| 171911LOEA |  | FY11 Constrctn Proj Office Proj Mngmnt CR11-007 Reductions |  | 227d | 2010-11-01 | 2011-09-30 | 171910LOE FS+21d | 20d | 0d |  | SUPPLIES & MATERIALS; ELEC ENG [-1760 h]; SCIENTIST [-704 h] | -360,226.29 | RODE C | 1 | 1 |  | CLAUS R |  |  |  |  |  |  |  |  |  |  |  |  |  |  |  |  |  |  |  |  |  |  |  |  |  | 10-037 | 10-050 | 11-007 |  |  |  |  |  |  |  |  |  |
| 171911LOEB |  | FY11 Constrctn Proj Office Proj Mngmnt CR11-007 |  | 227d | 2010-11-01 | 2011-09-30 | 171910LOE FS+21d | 20d | 0d |  | OFFICE [880 h]; SR STAFF [352 h]; MECH ENG [5016 h]; DIRECTORATE [688 h] | 531,076.24 | RODE C | 1 | 1 |  | CLAUS R |  |  |  |  |  |  |  |  |  |  |  |  |  |  |  |  |  |  |  |  |  |  |  |  |  | 10-037 | 10-050 | 11-007 |  |  |  |  |  |  |  |  |  |
| 171912LOE |  | FY12 Constrctn Proj Office Proj Mngmnt Part A |  | 120d | 2011-10-03 | 2012-03-30 | 171911LOE, 171911LOEB, 171911LOEA | 20d | 0d |  | DIRECTORATE [1410.85 h]; SUPPLIES & MATERIALS; MECH ENG [3291.98 h]; SR STAFF [2864.45 h]; ADMIN [855.06 h]; OFFICE [1710.12 h]; ELEC ENG [855.06 h] | 1,003,411.03 | RODE C | 1 | 1 |  | CLAUS R |  |  |  |  |  |  |  |  |  |  |  |  |  |  |  |  |  |  |  |  |  |  |  |  |  | 10-037 | 10-050 | 11-007 | 12-038 |  |  |  |  |  |  |  |  |
| 171912LOEA |  | FY12 Constrctn Proj Office Proj Mngmnt Part B |  | 127d | 2012-04-02 | 2012-09-28 | 171912LOE | 20d | 0d |  | OFFICE [1760 h]; ELEC ENG [880 h]; DIRECTORATE [1452 h]; SUPPLIES & MATERIALS; MECH ENG [1760 h]; SR STAFF [2200 h]; ADMIN [880 h] | 833,360.68 | RODE C | 1 | 1 |  | CLAUS R |  |  |  |  |  |  |  |  |  |  |  |  |  |  |  |  |  |  |  |  |  |  |  |  |  | 10-037 | 10-050 | 11-007 | 12-038 |  |  |  |  |  |  |  |  |
| 171913LOE |  | FY13 Constrctn Proj Office Proj Mngmnt Part A |  | 120d | 2012-10-01 | 2013-03-29 | 171912LOE, 13451912LOE, 171912LOEA | 20d | 0d |  | ELEC ENG [880 h]; OFFICE [1760 h]; SUPPLIES & MATERIALS; SR STAFF [2200 h]; DIRECTORATE [1452 h]; ADMIN [880 h]; MECH ENG [1760 h] | 859,930.96 | RODE C | 1 | 1 |  | CLAUS R |  |  |  |  |  |  |  |  |  |  |  |  |  |  |  |  |  |  |  |  |  |  |  |  |  | 10-037 | 10-050 | 11-007 | 12-038 |  |  |  |  |  |  |  |  |
| 171913LOEA |  | FY13 Constrctn Proj Office Proj Mngmnt Part B |  | 108d | 2013-04-01 | 2013-08-30 | 171913LOE | 20d |  |  | OFFICE [1485 h]; SUPPLIES & MATERIALS; SR STAFF [1856.25 h]; DIRECTORATE [1225.13 h]; ADMIN [742.5 h]; ELEC ENG [742.5 h]; MECH ENG [1485 h] | 725,567.21 | RODE C | 1 | 1 |  | CLAUS R |  |  |  |  |  |  |  |  |  |  |  |  |  |  |  |  |  |  |  |  |  |  | 13-014 |  |  | 10-037 | 10-050 | 11-007 | 12-038 |  |  |  |  |  |  |  |  |
| 171950 |  | Re-Baseline Actuals Adjustment |  | 1d | 2013-08-30 | 2013-08-30 | 9-130M FS+227d | 20d |  |  | PROCUREMENT>$50K 69 NO ESCALATION | -836,039.64 | RODE C | 1 | 1 |  | CLAUS R |  |  |  |  |  |  |  |  |  |  |  |  |  |  |  |  |  |  |  |  |  |  | 13-014 | ADJ |  |  |  |  |  |  |  |  |  |  |  |  |  |
| 271913LOEB |  | FY13 Constrctn Proj Office Proj Mngmnt Part B |  | 20d | 2013-09-03 | 2013-09-30 | 9-130M FS+228d | 311d | 0d | 8/5 M-F w/JLAB Holidays ReBaseline | PROCUREMENT<$50K 60; SCIENTIST [14.07 h]; OFFICE [140.79 h]; SUPPLIES & MATERIALS; SR STAFF [179.51 h]; DIRECTORATE [123.18 h]; ADMIN [70.4 h]; ELEC ENG [35.2 h]; MECH ENG [140.79 h] | 69,025.2 | RODE C | 1 | 1 |  | CLAUS R |  |  |  |  |  |  |  |  |  |  |  |  |  |  |  |  |  |  |  |  |  |  |  |  |  | 10-037 | 10-050 | 11-007 | 12-038 | 271913LOEB | y | PE | PE | 13-015 | PR | OB |  |
| 271914LOE |  | FY14 Constrctn Proj Office Proj Mngmnt |  | 247d | 2013-10-01 | 2014-09-30 | 271913LOEB | 311d | 0d | 8/5 M-F w/JLAB Holidays ReBaseline | SR STAFF [2244 h]; DIRECTORATE [1737.4 h]; ADMIN [880 h]; ELEC ENG [440 h]; MECH ENG [1760 h]; SCIENTIST [176 h]; OFFICE [1760 h]; SUPPLIES & MATERIALS | 930,872.11 | RODE C | 1 | 1 |  | CLAUS R |  |  |  |  |  |  |  |  |  |  |  |  |  |  |  |  |  |  |  |  |  |  |  |  |  | 10-037 | 10-050 | 11-007 | 12-038 | 271914LOE |  | PE | PE | 13-015 | PR |  | 14-001 |

| ID | WBS | Activity | Duration | Start | Finish | Predecessors | Total float | Free float | Calendar | Resources | Cost | RESP - Responsibility | STRT%COMP for CM EVM | FNSH%COMP for CM EVM | CR 07-024 | CAM RESPONSIBLE | CR 09-012 | CR 13-014 | Original Activity ID Rebaseline | CR 09-028 | CR 09-028 Repair | CR 11-026 | CR 12-025 | CR 13-015 | Post Rebaseline | CR 12-029 | CR 12-050 | 12 GeV 1st level Critical Path | CR 11-006 | CR 12-021 | CR 13-007 | EVMS Reporting Codes | CR 12-012 | CR 12-036 | CR 12-054 | CR 13-006 | CR 12-024 | CR 13-002 | CR 13-010 | GROP Group | CR 12-035 | ReBaseline Actuals Adjustment | CR 12-040 | BOE Labor | CR 14-001 | HALL D Related Milestones | CR 09-014 | CR 11-035 | CR 11-046 |
| --- | --- | --- | --- | --- | --- | --- | --- | --- | --- | --- | --- | --- | --- | --- | --- | --- | --- | --- | --- | --- | --- | --- | --- | --- | --- | --- | --- | --- | --- | --- | --- | --- | --- | --- | --- | --- | --- | --- | --- | --- | --- | --- | --- | --- | --- | --- | --- | --- | --- |
|  | 2 | **1.7.2 OFFICE OF PROJECT MANAGEMENT** |  | 2008-10-01 | 2013-08-30 |  |  |  |  |  |  |  |  |  |  |  |  |  |  |  |  |  |  |  |  |  |  |  |  |  |  |  |  |  |  |  |  |  |  |  |  |  |  |  |  |  |  |  |  |
| 172909LOE |  | FY09 OPM Proj Mngmnt | 248d | 2008-10-01 | 2009-09-30 | 1251908LOEB | 20d | 0d |  |  |  | RODE C | 1 | 1 | 07-024 | CLAUS R | 09-012 |  |  |  |  |  |  |  |  |  |  |  |  |  |  |  |  |  |  |  |  |  |  |  |  |  |  |  |  |  |  |  |  |
| 172910LOE |  | FY10 OPM Proj Mngmnt | 248d | 2009-10-01 | 2010-09-30 | 172909LOE | 20d | 0d |  |  |  | RODE C | 1 | 1 | 07-024 | CLAUS R | 09-012 |  |  |  |  |  |  |  |  |  |  |  |  |  |  |  |  |  |  |  |  |  |  |  |  |  |  |  |  |  |  |  |  |
| 172911LOE |  | FY11 OPM Proj Mngmnt | 248d | 2010-10-01 | 2011-09-30 | 172910LOE | 20d | 0d |  |  |  | RODE C | 1 | 1 | 07-024 | CLAUS R | 09-012 |  |  |  |  |  |  |  |  |  |  |  |  |  |  |  |  |  |  |  |  |  |  |  |  |  |  |  |  |  |  |  |  |
| 172912LOE |  | FY12 OPM Proj Mngmnt | 247d | 2011-10-03 | 2012-09-28 | 1356911LOE, 1354911LOE, 172911LOE, 13614911LOE, 1355911LOE, 13461050LOE, 1351911LOE, 13462015LOE | 20d | 0d |  |  |  | RODE C | 1 | 1 | 07-024 | CLAUS R | 09-012 |  |  |  |  |  |  |  |  |  |  |  |  |  |  |  |  |  |  |  |  |  |  |  |  |  |  |  |  |  |  |  |  |
| 172913LOE |  | FY13 OPM Proj Mngmnt | 228d | 2012-10-01 | 2013-08-30 | 1366912LOE, 13421912LOE, 13411912LOE, 1362912LOE, 13463045LOE, 172912LOE | 20d |  |  |  |  | RODE C | 1 | 1 | 07-024 | CLAUS R | 09-012 | 13-014 |  |  |  |  |  |  |  |  |  |  |  |  |  |  |  |  |  |  |  |  |  |  |  |  |  |  |  |  |  |  |  |
|  | 8 | **1.8 CONSTRUCTION PRE-OPS** |  | 2006-10-02 | 2017-08-02 |  |  |  |  |  |  |  |  |  |  |  |  |  |  |  |  |  |  |  |  |  |  |  |  |  |  |  |  |  |  |  |  |  |  |  |  |  |  |  |  |  |  |  |  |
| 28005 |  | Hall A Schedule Contingency Activity | 245d | 2014-03-06 | 2015-03-03 | 2-09M | 643d |  | 8/5 M-F w/JLAB Holidays ReBaseline |  |  | RODE C | 1 | 1 |  | CLAUS R | 09-012 |  | 28005 | 09-028 | 09-028 | 11-026 | 12-025 | 13-015 | PR |  |  |  |  |  |  |  |  |  |  |  |  |  |  |  |  |  |  |  |  |  |  |  |  |
| 28000 |  | Accelerator Schedule Contingency Activity | 125d | 2014-06-26 | 2014-12-23 | 2-25M, 2-03M, 23221023L FS-200d | 0d |  | 8/5 M-F w/JLAB Holidays ReBaseline |  |  | HARWOOD L | 1 | 1 |  | LEIGH H |  |  | 28000 |  |  | 11-026 | 12-025 | 13-015 | PR | 12-029 | 12-050 |  |  |  |  |  |  |  |  |  |  |  |  |  |  |  |  |  |  |  |  |  |  |
| 28010 |  | Hall D Schedule Contingency Activity | 245d | 2015-04-02 | 2016-03-29 | 3P-25M, 2-13M, 2553010a, 2531033 | 377d |  | 8/5 M-F w/JLAB Holidays ReBaseline |  |  | RODE C | 1 | 1 |  | CLAUS R |  |  | 28010 | 09-028 | 09-028 | 11-026 | 12-025 | 13-015 | PR |  |  | 1 | 11-006 | 12-021 | 13-007 |  |  |  |  |  |  |  |  |  |  |  |  |  |  |  |  |  |  |
| 28025 |  | Civil Schedule Contingency Activity | 245d | 2015-10-05 | 2016-09-28 | 2-38M | 249d |  | 8/5 M-F w/JLAB Holidays ReBaseline |  |  | RODE C | 1 | 1 |  | CLAUS R |  |  | 28025 | 09-028 | 09-028 | 11-026 | 12-025 | 13-015 | PR |  |  |  |  |  |  | M | 12-012 | 12-036 | 12-054 | 13-006 |  |  |  |  |  |  |  |  |  |  |  |  |  |
| 28020 |  | Hall C Schedule Contingency Activity | 370d | 2016-02-09 | 2017-07-31 | 243161020, 2-33M, 3P-22M | 43d |  | 8/5 M-F w/JLAB Holidays ReBaseline |  |  | RODE C | 1 | 1 |  | CLAUS R |  |  | 28020 | 09-028 | 09-028 | 11-026 | 12-025 | 13-015 | PR |  |  |  |  |  |  |  | 12-012 | 12-036 | 12-054 | 13-006 |  |  |  |  |  |  |  |  |  |  |  |  |  |
| 28015 |  | Hall B Schedule Contingency Activity | 370d | 2016-02-11 | 2017-08-02 | 2-37M, 3P-21M | 41d |  | 8/5 M-F w/JLAB Holidays ReBaseline |  |  | RODE C | 1 | 1 |  | CLAUS R |  |  | 28015 | 09-028 | 09-028 | 11-026 | 12-025 | 13-015 | PR |  |  |  |  |  |  |  |  |  |  |  | 12-024 | 13-002 | 13-010 |  |  |  |  |  |  |  |  |  |  |
|  | 1 | **1.8.1 CONSTRUCTION ACCELERATOR PRE-OPS** |  | 2006-10-02 | 2016-02-10 |  |  |  |  |  |  |  |  |  |  |  |  |  |  |  |  |  |  |  |  |  |  |  |  |  |  |  |  |  |  |  |  |  |  |  |  |  |  |  |  |  |  |  |  |
|  | 1 | **1.8.1.1 CONSTRUCTION ACCELERATOR PRE-OPS BEAM COMMISIONING** |  | 2006-10-02 | 2016-02-10 |  |  |  |  |  |  |  |  |  |  |  |  |  |  |  |  |  |  |  |  |  |  |  |  |  |  |  |  |  |  |  |  |  |  |  |  |  |  |  |  |  |  |  |  |
| 1811001 |  | Accel ARR Process | 60d | 2006-10-02 | 2007-01-03 |  | 1674d |  |  |  |  | HARWOOD L | 1 | 1 |  | LEIGH H |  |  |  |  |  | 11-026 | 12-025 |  |  | 12-029F |  |  |  |  |  |  |  |  |  |  |  |  |  | ACCL |  |  |  |  |  |  |  |  |  |
| 1811019 |  | H-A ARR Process | 20d | 2012-11-15 | 2012-12-14 | 14132020, 14151010a, 14153020, 14152025 | 1185d |  |  |  |  | HARWOOD L | 1 | 1 |  | LEIGH H |  |  |  |  |  | 11-026 |  | 13-015 |  |  |  |  |  |  |  |  |  |  |  |  |  |  |  | ACCL | 12-035 |  |  |  |  |  |  |  |  |
| 1811070 |  | Re-Baseline Actuals Adjustment | 1d | 2013-08-30 | 2013-08-30 | 9-130M FS+227d | 20d |  |  | PROCUREMENT>$50K 69 NO ESCALATION |  | HARWOOD L | 1 | 1 |  | LEIGH H |  | 13-014 |  |  |  |  |  |  |  |  |  |  |  |  |  |  |  |  |  |  |  |  |  |  |  | ADJ |  |  |  |  |  |  |  |
| 2811001 |  | Accel ARR Process | 44d | 2013-10-11 | 2013-12-13 | 2812000 FS-52d, 2811000 FS-40d | 0d |  | 8/5 M-F w/JLAB Holidays ReBaseline |  |  | HARWOOD L | 1 | 1 |  | LEIGH H |  |  | 2811001 |  |  | 11-026 | 12-025 | 13-015 | PR | 12-029F |  |  |  |  |  |  |  |  |  |  |  |  |  | ACCL |  |  |  |  |  |  |  |  |  |
| 2811019 |  | H-A ARR Process | 20d | 2013-10-14 | 2013-11-08 | 3A-43M, 2-08M | 87d | 68d | 8/5 M-F w/JLAB Holidays ReBaseline |  |  | HARWOOD L | 1 | 1 |  | LEIGH H |  |  | 2811019 |  |  | 11-026 |  | 13-015 | PR |  |  |  |  |  |  |  |  |  |  |  |  |  |  | ACCL | 12-035 |  |  |  |  |  |  |  |  |
| 2811000 |  | Accel Hot Check-out | 38d | 2013-10-15 | 2013-12-09 | 4A-10M | 0d |  | 8/5 M-F w/JLAB Holidays ReBaseline | COMP SCIENT [480 h]; MECH TECH [400 h]; MECH ENG [160 h]; SCIENTIST [80 h]; ELEC ENG [240 h]; ELEC TECH [1728 h] | 169,657.12 | HARWOOD L | 1 | 1 |  | LEIGH H | 09-012 |  | 2811000 |  |  | 11-026 | 12-025 | 13-015 | PR | 12-029F |  |  |  |  |  |  |  |  |  |  |  |  |  |  |  |  | 12-040 | PE | 14-001 |  |  |  |  |
| 2811005 |  | Accel Commisioning | 25d | 2013-11-14 | 2013-12-20 | 32-05M | 0d |  | 8/5 M-F w/JLAB Holidays ReBaseline | COMP SCIENT [1600 h]; MECH ENG [400 h]; MECH TECH [600 h]; ELEC ENG [600 h]; ELEC TECH [3720 h]; SCIENTIST [600 h] | 435,040.8 | HARWOOD L | 1 | 1 |  | LEIGH H | 09-012 |  | 2811005 |  |  | 11-026 | 12-025 | 13-015 | PR | 12-029F |  |  |  |  |  |  |  |  |  |  |  |  |  |  |  |  |  | PE | 14-001 |  |  |  |  |
| 2811020 |  | H-A Beam Cmmssng | 3d | 2014-03-03 | 2014-03-05 | 4A-06M, 23643175M, 4A-11M FS-40d, 23613050, 23427067, 3P-12M, 2367050 | 18d | 0d | 8/5 M-F w/JLAB Holidays ReBaseline | SCIENTIST [60 h]; MECH TECH [40 h]; ELEC ENG [20 h]; ELEC TECH [332 h]; MECH ENG [20 h]; COMP SCIENT [40 h] | 27,795.08 | HARWOOD L | 1 | 1 |  | LEIGH H | 09-012 |  | 2811020 |  |  | 11-026 | 12-025 | 13-015 | PR |  |  |  |  |  |  |  |  |  |  |  |  |  |  |  |  |  |  | PE | 14-001 |  |  |  |  |
| 2811064 |  | H-D ARR Process | 75d | 2014-08-05 | 2014-11-18 | 2-12M FS-40d, 3A-53M | 8d | 0d | 8/5 M-F w/JLAB Holidays ReBaseline |  |  | HARWOOD L | 1 | 1 |  | LEIGH H |  |  | 2811064 | 09-028 | 09-028 | 11-026 |  | 13-015 | PR |  |  |  | 11-006 | 12-021 | 13-007 |  |  |  |  |  |  |  |  | ACCL |  |  |  |  |  | D |  |  |  |
| 2811065 |  | H-D Beam Cmmssng | 15d | 2014-11-19 | 2014-12-11 | 3P-16M | 8d | 0d | 8/5 M-F w/JLAB Holidays ReBaseline | COMP SCIENT [240 h]; SCIENTIST [360 h]; ELEC ENG [120 h]; MECH TECH [240 h]; ELEC TECH [1992 h]; MECH ENG [120 h] | 166,770.48 | HARWOOD L | 1 | 1 |  | LEIGH H | 09-012 |  | 2811065 | 09-028 | 09-028 | 11-026 |  | 13-015 | PR |  |  |  | 11-006 | 12-021 | 13-007 |  |  |  |  |  |  |  |  |  |  |  |  | PE | 14-001 | D | 09-014 |  |  |
| 2811034 |  | H-B ARR Process | 40d | 2015-11-19 | 2016-01-27 | 2-36M FS-20d, 3A-44M | 36d | 0d | 8/5 M-F w/JLAB Holidays ReBaseline |  |  | HARWOOD L | 1 | 1 |  | LEIGH H |  |  | 2811034 |  |  | 11-026 |  | 13-015 | PR |  |  |  |  |  |  |  |  |  |  |  | 12-024 | 13-002 | 13-010 | ACCL |  |  |  |  |  |  |  | 11 -035 |  |
| 2811049 |  | H-C ARR Process | 40d | 2015-11-24 | 2016-02-01 | 3A-46M, 2-32M FS-20d | 38d | 0d | 8/5 M-F w/JLAB Holidays ReBaseline |  |  | HARWOOD L | 1 | 1 |  | LEIGH H |  |  | 2811049 | 09-028 | 09-028 | 11-026 |  | 13-015 | PR |  |  |  |  |  |  |  | 12-012 | 12-036 | 12-054 | 13-006 |  |  |  | ACCL |  |  |  |  |  |  |  |  | 11-046 |
| 2811035 |  | H-B Beam Cmmssng | 10d | 2016-01-28 | 2016-02-10 | 3P-20M | 36d | 0d | 8/5 M-F w/JLAB Holidays ReBaseline | ELEC ENG [80 h]; MECH TECH [160 h]; ELEC TECH [1328 h]; MECH ENG [80 h]; COMP SCIENT [160 h]; SCIENTIST [240 h] | 111,180.32 | HARWOOD L | 1 | 1 |  | LEIGH H | 09-012 |  | 2811035 | 09-028 | 09-028 | 11-026 |  | 13-015 | PR |  |  |  |  |  |  |  |  |  |  |  | 12-024 | 13-002 | 13-010 |  |  |  |  | PE | 14-001 |  |  |  |  |
| 2811050 |  | H-C Beam Cmmssng | 5d | 2016-02-02 | 2016-02-08 | 3P-18M, 32-05M | 38d | 0d | 8/5 M-F w/JLAB Holidays ReBaseline | ELEC ENG [40 h]; MECH ENG [40 h]; COMP SCIENT [80 h]; MECH TECH [80 h]; SCIENTIST [120 h]; ELEC TECH [664 h] | 55,590.16 | HARWOOD L | 1 | 1 |  | LEIGH H | 09-012 |  | 2811050 | 09-028 | 09-028 | 11-026 |  | 13-015 | PR |  |  |  |  |  |  |  | 12-012 | 12-036 | 12-054 | 13-006 |  |  |  |  |  |  |  | PE | 14-001 |  |  |  |  |

| ID | WBS | Activity | Duration | Start | Finish | Predecessors | Total float | Free float | Calendar | Resources | Cost | Original Activity ID Rebaseline | RESP - Responsibility | STRT%COMP for CM EVM | FNSH%COMP for CM EVM | Advance Purchase Plan > 500K | CAM RESPONSIBLE | CR 11-026 | CR 12-025 | CR 12-029 | CR 12-040 | BOE Procurement | BOE Labor | CR 13-015 | Post Rebaseline | Temple/Lehman | CR 14-001 | CR 09-012 | HALL D Related Milestones | CR 09-014 | CR 09-028 | CR 09-028 Repair | CR 11-006 | CR 12-021 | CR 13-007 | CR 08-016 | CR 12-024 | CR 13-002 | CR 13-010 | CR 12-012 | CR 12-036 | CR 12-054 | CR 13-006 | CR 08-050 | CR 10-031 | CR 10-064 | CR 10-066 | CR 12-018 | CR 12-028 | CR 13-014 | ReBaseline Actuals Adjustment | BOE Expenses | BOE Adder | CR 08-009 | CR 10-028 | CR 13-009 | CR 13-003 |
| --- | --- | --- | --- | --- | --- | --- | --- | --- | --- | --- | --- | --- | --- | --- | --- | --- | --- | --- | --- | --- | --- | --- | --- | --- | --- | --- | --- | --- | --- | --- | --- | --- | --- | --- | --- | --- | --- | --- | --- | --- | --- | --- | --- | --- | --- | --- | --- | --- | --- | --- | --- | --- | --- | --- | --- | --- | --- |
|  | 2 | **1.8.1.2 CONSTRUCTION ACCELERATOR PRE-OPS UTILITIES** |  | 2013-10-15 | 2016-02-10 |  |  |  |  |  |  |  |  |  |  |  |  |  |  |  |  |  |  |  |  |  |  |  |  |  |  |  |  |  |  |  |  |  |  |  |  |  |  |  |  |  |  |  |  |  |  |  |  |  |  |  |  |
| 2812000 |  | Accel Hot Check-out (Utilities) | 32d | 2013-10-15 | 2013-11-27 | 4A-10M | 18d |  | 8/5 M-F w/JLAB Holidays ReBaseline | PROCUREMENT>$50K 69; SR STAFF [102.4 h]; ELEC ENG [102.4 h]; ELEC TECH [102.4 h]; MECH ENG [102.4 h]; MECH TECH [102.4 h] | 235,442.44 | 2812000 | HARWOOD L | 1 | 1 | APP | LEIGH H | 11-026 | 12-025 | 12-029F | 12-040 | PE | PE | 13-015 | PR | LR13 | 14-001 |  |  |  |  |  |  |  |  |  |  |  |  |  |  |  |  |  |  |  |  |  |  |  |  |  |  |  |  |  |  |
| 2812005 |  | Accel Beam Commissioning (Utilities) | 25d | 2013-11-14 | 2013-12-20 | 32-05M | 0d |  | 8/5 M-F w/JLAB Holidays ReBaseline | MECH TECH [256.8 h]; PROCUREMENT>$50K 69; SR STAFF [256.8 h]; ELEC ENG [256.8 h]; ELEC TECH [256.8 h]; MECH ENG [256.8 h] | 703,438.53 | 2812005 | HARWOOD L | 1 | 1 | APP | LEIGH H | 11-026 | 12-025 | 12-029F |  | PE | PE | 13-015 | PR | LR13 | 14-001 | 09-012 |  |  |  |  |  |  |  |  |  |  |  |  |  |  |  |  |  |  |  |  |  |  |  |  |  |  |  |  |  |
| 2812065 |  | H-A Beam Cmmssng (Utilities) | 3d | 2014-02-28 | 2014-03-04 | 3P-12M | 19d | 1d | 8/5 M-F w/JLAB Holidays ReBaseline | PROCUREMENT>$50K 69; MECH TECH [31 h]; MECH ENG [31 h]; ELEC ENG [31 h]; ELEC TECH [31 h] | 123,140.21 | 2812065 | HARWOOD L | 1 | 1 | APP | LEIGH H | 11-026 | 12-025 |  |  | PE | PE | 13-015 | PR | LR13 | 14-001 | 09-012 |  |  |  |  |  |  |  |  |  |  |  |  |  |  |  |  |  |  |  |  |  |  |  |  |  |  |  |  |  |
| 2812050 |  | H-D Beam Cmmssng (Utilities) | 15d | 2014-11-19 | 2014-12-11 | 3P-16M | 8d | 0d | 8/5 M-F w/JLAB Holidays ReBaseline | MECH ENG [185 h]; ELEC ENG [185 h]; ELEC TECH [185 h]; PROCUREMENT>$50K 69; MECH TECH [185 h] | 599,290.65 | 2812050 | HARWOOD L | 1 | 1 | APP | LEIGH H | 11-026 |  |  |  | PE | PE | 13-015 | PR | LR13 | 14-001 | 09-012 | D | 09-014 | 09-028 | 09-028 | 11-006 | 12-021 | 13-007 |  |  |  |  |  |  |  |  |  |  |  |  |  |  |  |  |  |  |  |  |  |  |
| 2812020 |  | H-B Beam Cmmssng (Utilities) | 10d | 2016-01-28 | 2016-02-10 | 3P-20M | 36d | 0d | 8/5 M-F w/JLAB Holidays ReBaseline | PROCUREMENT>$50K 69; ELEC TECH [123 h]; MECH TECH [123 h]; ELEC ENG [123 h]; MECH ENG [123 h] | 398,413.83 | 2812020 | HARWOOD L | 1 | 1 | APP | LEIGH H | 11-026 |  |  |  | PE | PE | 13-015 | PR | LR13 | 14-001 | 09-012 |  |  | 09-028 | 09-028 |  |  |  | 08-016 | 12-024 | 13-002 | 13-010 |  |  |  |  |  |  |  |  |  |  |  |  |  |  |  |  |  |  |
| 2812035 |  | H-C Beam Cmmssng (Utilities) | 5d | 2016-02-02 | 2016-02-08 | 3P-18M | 38d | 0d | 8/5 M-F w/JLAB Holidays ReBaseline | MECH ENG [63 h]; ELEC TECH [63 h]; MECH TECH [63 h]; ELEC ENG [63 h]; PROCUREMENT>$50K 69 | 276,449.63 | 2812035 | HARWOOD L | 1 | 1 | APP | LEIGH H | 11-026 |  |  |  | PE | PE | 13-015 | PR | LR13 | 14-001 | 09-012 |  |  | 09-028 | 09-028 |  |  |  | 08-016 |  |  |  | 12-012 | 12-036 | 12-054 | 13-006 |  |  |  |  |  |  |  |  |  |  |  |  |  |  |
|  | 3 | **1.8.1.3 ACCELERATOR PRE-OPS CHECKOUT** |  | 2012-10-01 | 2014-06-25 |  |  |  |  |  |  |  |  |  |  |  |  |  |  |  |  |  |  |  |  |  |  |  |  |  |  |  |  |  |  |  |  |  |  |  |  |  |  |  |  |  |  |  |  |  |  |  |  |  |  |  |  |
|  | 1 | **1.8.1.3.1 CRYOMODULES ACCELERATOR PRE-OPS** |  | 2013-01-29 | 2014-02-28 |  |  |  |  |  |  |  |  |  |  |  |  |  |  |  |  |  |  |  |  |  |  |  |  |  |  |  |  |  |  |  |  |  |  |  |  |  |  |  |  |  |  |  |  |  |  |  |  |  |  |  |  |
|  | 5 | **1.8.1.3.1.5 CRYOMODULES IN-TUNNEL CHECKOUT** |  | 2013-01-29 | 2014-02-28 |  |  |  |  |  |  |  |  |  |  |  |  |  |  |  |  |  |  |  |  |  |  |  |  |  |  |  |  |  |  |  |  |  |  |  |  |  |  |  |  |  |  |  |  |  |  |  |  |  |  |  |  |
| 181315000 |  | In-Tunnel Checkout and Commisioning Cryomodule #3 5th | 24d | 2013-01-29 | 2013-03-04 | 132122025M, 131505005 FS+121d, 181321000, 131503000 | 35d | 0d |  | SR STAFF [40 h]; COMP SCIENT [16 h]; ELEC ENG [240 h]; ELEC TECH [120 h]; SUPPLIES & MATERIALS; SCIENTIST [40 h]; MECH ENG [80 h]; MECH TECH [160 h] | 50,221.29 |  | HOGAN J | 1 | 1 |  | JOHN H |  |  |  | 12-040 |  |  |  |  |  |  |  |  |  |  |  |  |  |  |  |  |  |  |  |  |  |  | 08-050 | 10-031 | 10-064 | 10-066 | 12-018 | 12-028 |  |  |  |  |  |  |  |  |
| 181315005 |  | In-Tunnel Checkout and Commisioning Cryomodule #6 | 24d | 2013-03-05 | 2013-04-05 | 181321005, 181315000, 131506000 | 35d | 0d |  | SCIENTIST [40 h]; ELEC ENG [240 h]; ELEC TECH [120 h]; COMP SCIENT [16 h]; MECH ENG [80 h]; SR STAFF [40 h]; MECH TECH [160 h]; SUPPLIES & MATERIALS | 50,221.29 |  | HOGAN J | 1 | 1 |  | JOHN H |  |  |  | 12-040 |  |  |  |  |  |  |  |  |  |  |  |  |  |  |  |  |  |  |  |  |  |  | 08-050 | 10-031 | 10-064 | 10-066 | 12-018 | 12-028 |  |  |  |  |  |  |  |  |
| 181315010 |  | In-Tunnel Checkout and Commisioning Cryomodule #7 | 25d | 2013-04-08 | 2013-05-10 | 131507000, 181315005, 181321010 | 35d | 0d |  | SR STAFF [40 h]; COMP SCIENT [16 h]; ELEC ENG [240 h]; ELEC TECH [120 h]; MECH ENG [80 h]; MECH TECH [160 h]; SUPPLIES & MATERIALS; SCIENTIST [40 h] | 50,221.29 |  | HOGAN J | 1 | 1 |  | JOHN H |  |  |  | 12-040 |  |  |  |  |  |  |  |  |  |  |  |  |  |  |  |  |  |  |  |  |  |  | 08-050 | 10-031 | 10-064 | 10-066 | 12-018 | 12-028 |  |  |  |  |  |  |  |  |
| 181315015 |  | In-Tunnel Checkout and Commisioning Cryomodule #8 | 24d | 2013-05-13 | 2013-06-14 | 181315010, 181321015, 131508000 | 35d | 0d |  | ELEC ENG [240 h]; COMP SCIENT [16 h]; SR STAFF [40 h]; MECH ENG [80 h]; MECH TECH [160 h]; SUPPLIES & MATERIALS; SCIENTIST [40 h]; ELEC TECH [120 h] | 50,221.29 |  | HOGAN J | 1 | 1 |  | JOHN H |  |  |  | 12-040 |  |  |  |  |  |  |  |  |  |  |  |  |  |  |  |  |  |  |  |  |  |  | 08-050 | 10-031 | 10-064 | 10-066 | 12-018 | 12-028 |  |  |  |  |  |  |  |  |
| 181315020 |  | In-Tunnel Checkout and Commisioning Cryomodule #9 | 24d | 2013-06-17 | 2013-07-19 | 131509000, 181315015, 181321020 | 35d | 0d |  | MECH TECH [160 h]; SCIENTIST [40 h]; SR STAFF [40 h]; SUPPLIES & MATERIALS; ELEC ENG [240 h]; ELEC TECH [120 h]; COMP SCIENT [16 h]; MECH ENG [80 h] | 50,221.29 |  | HOGAN J | 1 | 1 |  | JOHN H |  |  |  | 12-040 |  |  |  |  |  |  |  |  |  |  |  |  |  |  |  |  |  |  |  |  |  |  | 08-050 | 10-031 | 10-064 | 10-066 | 12-018 | 12-028 |  |  |  |  |  |  |  |  |
| 181315025 |  | In-Tunnel Checkout and Commisioning Cryomodule #10 | 25d | 2013-07-22 | 2013-08-23 | 181315020, 181321025, 131510000 | 35d | 0d |  | MECH ENG [80 h]; ELEC ENG [240 h]; SUPPLIES & MATERIALS; SCIENTIST [40 h]; SR STAFF [40 h]; ELEC TECH [120 h]; COMP SCIENT [16 h]; MECH TECH [160 h] | 50,221.29 |  | HOGAN J | 1 | 1 |  | JOHN H |  |  |  | 12-040 |  |  |  |  |  |  |  |  |  |  |  |  |  |  |  |  |  |  |  |  |  |  | 08-050 | 10-031 | 10-064 | 10-066 | 12-018 | 12-028 |  |  |  |  |  |  |  |  |
| 181315030 |  | Re-Baseline Actuals Adjustment | 1d | 2013-08-30 | 2013-08-30 | 9-130M FS+227d | 20d |  |  | PROCUREMENT>$50K 69 NO ESCALATION | -108,120.57 |  | HOGAN J | 1 | 1 |  | JOHN H |  |  |  |  |  |  |  |  |  |  |  |  |  |  |  |  |  |  |  |  |  |  |  |  |  |  |  |  |  |  |  |  | 13-014 | ADJ |  |  |  |  |  |  |
| 281315015 |  | In-Tunnel Checkout and Commisioning Cryomodule #8 | 14d | 2013-09-03 | 2013-09-20 | 9-130M FS+228d | 36d | 15d | 8/5 M-F w/JLAB Holidays ReBaseline | ELEC ENG [112.83 h]; COMP SCIENT [7.52 h]; SR STAFF [18.8 h]; MECH ENG [37.61 h]; MECH TECH [75.22 h]; SUPPLIES & MATERIALS; SCIENTIST [18.8 h]; ELEC TECH [56.41 h] | 24,872.75 | 281315015 | HOGAN J | 1 | 1 |  | JOHN H |  |  |  | 12-040 | PE | PE | 13-015 | PR |  |  |  |  |  |  |  |  |  |  |  |  |  |  |  |  |  |  | 08-050 | 10-031 | 10-064 | 10-066 | 12-018 | 12-028 |  |  | PE | YES |  |  |  |  |
| 281315025 |  | In-Tunnel Checkout and Commisioning Cryomodule #10 FY13 | 20d | 2013-09-03 | 2013-09-30 | 281321025 FS-5d | 21d | 0d | 8/5 M-F w/JLAB Holidays ReBaseline | MECH ENG [12.97 h]; ELEC ENG [38.91 h]; SUPPLIES & MATERIALS; SCIENTIST [6.48 h]; SR STAFF [6.48 h]; ELEC TECH [19.45 h]; COMP SCIENT [2.59 h]; MECH TECH [25.94 h] | 8,576.96 | 281315025 | HOGAN J | 1 | 1 |  | JOHN H |  |  |  | 12-040 | PE | PE | 13-015 | PR |  |  |  |  |  |  |  |  |  |  |  |  |  |  |  |  |  |  | 08-050 | 10-031 | 10-064 | 10-066 | 12-018 | 12-028 |  |  | PE | YES |  |  |  |  |
| 281315030 |  | Installation & Test of Individual Heater Control & Piezo Operation FY13 | 20d | 2013-09-03 | 2013-09-30 | 9-130M FS+228d | 207d | 0d | 8/5 M-F w/JLAB Holidays ReBaseline | MECH ENG [4.68 h]; ELEC ENG [14.03 h]; SUPPLIES & MATERIALS; SCIENTIST [2.34 h]; SR STAFF [2.34 h]; ELEC TECH [7.01 h]; COMP SCIENT [0.94 h]; MECH TECH [9.35 h] | 2,940.15 | 281315025 | HOGAN J | 1 | 1 |  | JOHN H |  |  |  |  |  |  | 13-015 | PR |  |  |  |  |  |  |  |  |  |  |  |  |  |  |  |  |  |  |  |  |  |  |  |  |  |  |  |  |  |  |  |  |
| 281315025a |  | In-Tunnel Checkout and Commisioning Cryomodule #10 FY14 | 9d | 2013-10-01 | 2013-10-11 | 281315025, 281321025 FS-5d | 21d | 0d | 8/5 M-F w/JLAB Holidays ReBaseline | MECH ENG [5.84 h]; ELEC ENG [17.51 h]; SUPPLIES & MATERIALS; SCIENTIST [2.92 h]; SR STAFF [2.92 h]; ELEC TECH [8.75 h]; COMP SCIENT [1.17 h]; MECH TECH [11.67 h] | 3,982.42 | 281315025 | HOGAN J | 1 | 1 |  | JOHN H |  |  |  | 12-040 | PE | PE | 13-015 | PR |  | 14-001 |  |  |  |  |  |  |  |  |  |  |  |  |  |  |  |  | 08-050 | 10-031 | 10-064 | 10-066 | 12-018 | 12-028 |  |  | PE | YES |  |  |  |  |
| 281315030a |  | Installation & Test of Individual Heater Control & Piezo Operation FY14 | 98d | 2013-10-01 | 2014-02-28 | 9-130M FS+228d, 281315030 | 207d |  | 8/5 M-F w/JLAB Holidays ReBaseline | MECH ENG [22.91 h]; ELEC ENG [68.73 h]; SUPPLIES & MATERIALS; SCIENTIST [11.46 h]; SR STAFF [11.46 h]; ELEC TECH [34.37 h]; COMP SCIENT [4.58 h]; MECH TECH [45.82 h] | 14,865.11 | 281315025 | HOGAN J | 1 | 1 |  | JOHN H |  |  |  |  |  |  | 13-015 | PR |  | 14-001 |  |  |  |  |  |  |  |  |  |  |  |  |  |  |  |  |  |  |  |  |  |  |  |  |  |  |  |  |  |  |
|  | 2 | **1.8.1.3.2 POWER PRE-OPS CHECKOUT** |  | 2012-10-30 | 2014-06-25 |  |  |  |  |  |  |  |  |  |  |  |  |  |  |  |  |  |  |  |  |  |  |  |  |  |  |  |  |  |  |  |  |  |  |  |  |  |  |  |  |  |  |  |  |  |  |  |  |  |  |  |  |
|  | 1 | **1.8.1.3.2.1 RF PRE-OPS CHECKOUT** |  | 2012-10-30 | 2013-11-06 |  |  |  |  |  |  |  |  |  |  |  |  |  |  |  |  |  |  |  |  |  |  |  |  |  |  |  |  |  |  |  |  |  |  |  |  |  |  |  |  |  |  |  |  |  |  |  |  |  |  |  |  |
| 181321000 |  | RF Sys Tests #5 (Install & SYS COMMIS) | 15d | 2012-10-30 | 2012-11-19 | 132121065M, 132112085M FS-36d | 76d | 41d |  | ELEC DES [56 h]; ELEC ENG [16 h]; ELEC TECH [100 h]; COMP SCIENT [16 h]; OFFICE [8 h]; SUPPLIES & MATERIALS | 10,216.3 |  | HOVATER C | 1 | 1 |  | BILL M |  |  |  | 12-040 |  |  |  |  |  |  |  |  |  |  |  |  |  |  |  |  |  |  |  |  |  |  |  | 10-031 |  | 10-066 | 12-018 | 12-028 |  |  |  |  | 08-009 | 10-028 | 13-009F |  |
| 181321005 |  | RF Sys Tests #6 (Install & SYS COMMIS) | 15d | 2013-01-17 | 2013-02-07 | 132112086M, 132121066M | 51d | 16d |  | OFFICE [8 h]; SUPPLIES & MATERIALS; ELEC DES [56 h]; ELEC ENG [16 h]; ELEC TECH [100 h]; COMP SCIENT [16 h] | 10,216.3 |  | HOVATER C | 1 | 1 |  | BILL M |  |  |  | 12-040 |  |  |  |  |  |  |  |  |  |  |  |  |  |  |  |  |  |  |  |  |  |  |  | 10-031 |  | 10-066 | 12-018 | 12-028 |  |  |  |  | 08-009 | 10-028 | 13-009 |  |
| 181321030 |  | RF Cavity Tests Cryomodule #3 (Install & SYS COMMIS) | 18d | 2013-02-06 | 2013-03-04 | 181315000 FS-18d, 181321000 | 157d | 122d |  | ELEC ENG [56 h]; ELEC DES [64 h]; ELEC TECH [60 h]; SCIENTIST [16 h]; OFFICE [8 h]; SUPPLIES & MATERIALS | 11,805.25 |  | HOVATER C | 1 | 1 |  | BILL M |  |  |  | 12-040 |  |  |  |  |  |  |  |  |  |  |  |  |  |  |  |  |  |  |  |  |  |  |  |  |  | 10-066 | 12-018 | 12-028 |  |  |  |  | 08-009 |  |  | 13-003 |
| 181321010 |  | RF Sys Tests #7 (Install & SYS COMMIS) | 15d | 2013-02-07 | 2013-02-28 | 132121067M, 132112087M | 61d | 26d |  | ELEC ENG [16 h]; ELEC TECH [100 h]; COMP SCIENT [16 h]; OFFICE [8 h]; SUPPLIES & MATERIALS; ELEC DES [56 h] | 10,216.3 |  | HOVATER C | 1 | 1 |  | BILL M |  |  |  | 12-040 |  |  |  |  |  |  |  |  |  |  |  |  |  |  |  |  |  |  |  |  |  |  |  | 10-031 |  | 10-066 | 12-018 | 12-028 |  |  |  |  | 08-009 | 10-028 | 13-009 |  |
| 181321015 |  | RF Sys Tests #8 (Install & SYS COMMIS) | 15d | 2013-02-27 | 2013-03-19 | 132121068M, 132112088M | 73d | 38d |  | ELEC DES [56 h]; ELEC ENG [16 h]; ELEC TECH [100 h]; COMP SCIENT [16 h]; OFFICE [8 h]; SUPPLIES & MATERIALS | 10,216.3 |  | HOVATER C | 1 | 1 |  | BILL M |  |  |  | 12-040 |  |  |  |  |  |  |  |  |  |  |  |  |  |  |  |  |  |  |  |  |  |  |  | 10-031 |  | 10-066 | 12-018 | 12-028 |  |  |  |  | 08-009 | 10-028 | 13-009 |  |
| 181321035 |  | RF Cavity Tests Cryomodule #6 (Install & SYS COMMIS) | 18d | 2013-03-13 | 2013-04-05 | 181315005 FS-18d, 181321005 | 133d | 98d |  | ELEC ENG [56 h]; ELEC DES [64 h]; ELEC TECH [60 h]; SCIENTIST [16 h]; OFFICE [8 h]; SUPPLIES & MATERIALS | 11,805.25 |  | HOVATER C | 1 | 1 |  | BILL M |  |  |  | 12-040 |  |  |  |  |  |  |  |  |  |  |  |  |  |  |  |  |  |  |  |  |  |  |  |  |  | 10-066 | 12-018 | 12-028 |  |  |  |  | 08-009 |  |  | 13-003 |
| 181321020 |  | RF Sys Tests #9 (Install & SYS COMMIS) | 15d | 2013-03-18 | 2013-04-05 | 132112089M, 132121069M | 84d | 49d |  | ELEC ENG [16 h]; ELEC TECH [100 h]; COMP SCIENT [16 h]; OFFICE [8 h]; SUPPLIES & MATERIALS; ELEC DES [56 h] | 10,216.3 |  | HOVATER C | 1 | 1 |  | BILL M |  |  |  | 12-040 |  |  |  |  |  |  |  |  |  |  |  |  |  |  |  |  |  |  |  |  |  |  |  | 10-031 |  | 10-066 | 12-018 | 12-028 |  |  |  |  | 08-009 | 10-028 | 13-009 |  |
| 181321025 |  | RF Sys Tests #10 (Install & SYS COMMIS) | 15d | 2013-04-04 | 2013-04-24 | 132121070M, 132112090M | 95d | 60d |  | ELEC TECH [100 h]; COMP SCIENT [16 h]; OFFICE [8 h]; SUPPLIES & MATERIALS; ELEC DES [56 h]; ELEC ENG [16 h] | 10,216.3 |  | HOVATER C | 1 | 1 |  | BILL M |  |  |  | 12-040 |  |  |  |  |  |  |  |  |  |  |  |  |  |  |  |  |  |  |  |  |  |  |  | 10-031 |  | 10-066 | 12-018 | 12-028 |  |  |  |  | 08-009 | 10-028 | 13-009 |  |
| 181321040 |  | RF Cavity Tests Cryomodule #7 (Install & SYS COMMIS) | 18d | 2013-04-17 | 2013-05-10 | 181315010 FS-18d, 181321010 | 108d | 73d |  | OFFICE [8 h]; SUPPLIES & MATERIALS; ELEC ENG [56 h]; ELEC DES [64 h]; ELEC TECH [60 h]; SCIENTIST [16 h] | 11,805.21 |  | HOVATER C | 1 | 1 |  | BILL M |  |  |  | 12-040 |  |  |  |  |  |  |  |  |  |  |  |  |  |  |  |  |  |  |  |  |  |  |  |  |  | 10-066 | 12-018 | 12-028 |  |  |  |  | 08-009 |  |  | 13-003 |
| 181321045 |  | RF Cavity Tests Cryomodule #8 (Install & SYS COMMIS) | 18d | 2013-05-21 | 2013-06-14 | 181315015 FS-18d, 181321015 | 84d | 49d |  | SUPPLIES & MATERIALS; ELEC ENG [56 h]; ELEC DES [64 h]; ELEC TECH [60 h]; SCIENTIST [16 h]; OFFICE [8 h] | 11,805.25 |  | HOVATER C | 1 | 1 |  | BILL M |  |  |  | 12-040 |  |  |  |  |  |  |  |  |  |  |  |  |  |  |  |  |  |  |  |  |  |  |  |  |  | 10-066 | 12-018 | 12-028 |  |  |  |  | 08-009 |  |  | 13-003 |
| 181321050 |  | RF Cavity Tests Cryomodule #9 (Install & SYS COMMIS) | 18d | 2013-06-25 | 2013-07-19 | 181321020, 181315020 FS-18d | 60d | 25d |  | ELEC ENG [56 h]; ELEC TECH [60 h]; ELEC DES [64 h]; SCIENTIST [16 h]; OFFICE [8 h]; SUPPLIES & MATERIALS | 11,805.25 |  | HOVATER C | 1 | 1 |  | BILL M |  |  |  | 12-040 |  |  |  |  |  |  |  |  |  |  |  |  |  |  |  |  |  |  |  |  |  |  |  |  |  | 10-066 | 12-018 | 12-028 |  |  |  |  | 08-009 |  |  | 13-003 |
| 181321055 |  | RF Cavity Tests Cryomodule #10 (Install & SYS COMMIS) | 18d | 2013-07-31 | 2013-08-23 | 181321025, 181315025 FS-18d | 35d | 0d |  | ELEC TECH [60 h]; SCIENTIST [16 h]; OFFICE [8 h]; SUPPLIES & MATERIALS; ELEC ENG [56 h]; ELEC DES [64 h] | 11,805.25 |  | HOVATER C | 1 | 1 |  | BILL M |  |  |  | 12-040 |  |  |  |  |  |  |  |  |  |  |  |  |  |  |  |  |  |  |  |  |  |  |  |  |  | 10-066 | 12-018 | 12-028 |  |  |  |  | 08-009 |  |  | 13-003 |
| 181321060 |  | Re-Baseline Actuals Adjustment | 1d | 2013-08-30 | 2013-08-30 | 9-130M FS+227d | 20d |  |  | PROCUREMENT>$50K 69 NO ESCALATION | -22,855.65 |  | HOVATER C | 1 | 1 |  | BILL M |  |  |  |  |  |  |  |  |  |  |  |  |  |  |  |  |  |  |  |  |  |  |  |  |  |  |  |  |  |  |  |  | 13-014 | ADJ |  |  |  |  |  |  |
| 281321025 |  | RF Sys Tests #10 (Install & SYS COMMIS) | 5d | 2013-09-03 | 2013-09-09 | 9-130M FS+228d | 21d | 0d | 8/5 M-F w/JLAB Holidays ReBaseline | ELEC TECH [60 h]; COMP SCIENT [9.6 h]; OFFICE [4.8 h]; SUPPLIES & MATERIALS; ELEC DES [33.6 h]; ELEC ENG [9.6 h] | 6,129.79 | 281321025 | HOVATER C | 1 | 1 |  | BILL M |  |  |  | 12-040 | PE | PE | 13-015 | PR | LR13 |  |  |  |  |  |  |  |  |  |  |  |  |  |  |  |  |  |  | 10-031 |  | 10-066 | 12-018 | 12-028 |  |  | PE | NO | 08-009 | 10-028 | 13-009 |  |
| 281321050 |  | RF Cavity Tests Cryomodule #9 (Install & SYS COMMIS) | 10d | 2013-09-03 | 2013-09-16 | 9-130M FS+228d | 65d | 37d | 8/5 M-F w/JLAB Holidays ReBaseline | ELEC TECH [42 h]; ELEC DES [44.8 h]; SCIENTIST [11.2 h]; OFFICE [5.6 h]; SUPPLIES & MATERIALS; ELEC ENG [39.2 h] | 8,263.68 | 281321050 | HOVATER C | 1 | 1 |  | BILL M |  |  |  | 12-040 | PE | PE | 13-015 | PR |  |  |  |  |  |  |  |  |  |  |  |  |  |  |  |  |  |  |  |  |  | 10-066 | 12-018 | 12-028 |  |  | PE | NO | 08-009 |  |  | 13-003 |
| 281321055 |  | RF Cavity Tests Cryomodule #10 (Install & SYS COMMIS) | 18d | 2013-10-14 | 2013-11-06 | 281315025a, 281315025, 281321025 | 28d | 0d | 8/5 M-F w/JLAB Holidays ReBaseline | ELEC TECH [60 h]; SCIENTIST [16 h]; OFFICE [8 h]; SUPPLIES & MATERIALS; ELEC ENG [56 h]; ELEC DES [64 h] | 12,181.29 | 281321055 | HOVATER C | 1 | 1 |  | BILL M |  |  |  | 12-040 | PE | PE | 13-015 | PR |  | 14-001 |  |  |  |  |  |  |  |  |  |  |  |  |  |  |  |  |  |  |  | 10-066 | 12-018 | 12-028 |  |  | PE | NO | 08-009 |  |  | 13-003 |

| ID | WBS | Activity | Duration | Start | Finish | Predecessors | Total float | Free float | Calendar | Resources | Cost | RESP - Responsibility | STRT%COMP for CM EVM | FNSH%COMP for CM EVM | CAM RESPONSIBLE | CR 13-014 | ReBaseline Actuals Adjustment | Original Activity ID Rebaseline | CR 10-028 | CR 10-040 | CR 11-055 | CR 12-029 | CR 12-050 | BOE Labor | CR 13-015 | Post Rebaseline | Temple/Lehman | CR 12-028 | CR 14-001 | BOE Expenses | Advance Purchase Plan > 500K | 12 GEV MAJOR PROCUREMENT CATAGORY | CR 12-018 | CR 12-032 | CR 12-040 | CR 11-036 | BOE NOTES | Calculated Remaining Total Cost | MONTHLY EV COST | CR 07-024 | CR 09-012 | CR 09-028 | CR 09-028 Repair | CR 11-026 | CR 12-025 | BOE Adder | EVMS Reporting Codes | CR 11-038 | CR 12-024 | CR 13-002 | CR 13-010 |
| --- | --- | --- | --- | --- | --- | --- | --- | --- | --- | --- | --- | --- | --- | --- | --- | --- | --- | --- | --- | --- | --- | --- | --- | --- | --- | --- | --- | --- | --- | --- | --- | --- | --- | --- | --- | --- | --- | --- | --- | --- | --- | --- | --- | --- | --- | --- | --- | --- | --- | --- | --- |
|  | 2 | **1.8.1.3.2.2 POWER SUPPLY TESTING** |  | 2013-08-30 | 2014-06-25 |  |  |  |  |  |  |  |  |  |  |  |  |  |  |  |  |  |  |  |  |  |  |  |  |  |  |  |  |  |  |  |  |  |  |  |  |  |  |  |  |  |  |  |  |  |  |
|  | 1 | **1.8.1.3.2.2.1 POWER SUPPLY TESTING** |  | 2013-08-30 | 2014-06-25 |  |  |  |  |  |  |  |  |  |  |  |  |  |  |  |  |  |  |  |  |  |  |  |  |  |  |  |  |  |  |  |  |  |  |  |  |  |  |  |  |  |  |  |  |  |  |
| 1813221000 |  | Re-Baseline Actuals Adjustment | 1d | 2013-08-30 | 2013-08-30 | 9-130M FS+227d | 20d |  |  | PROCUREMENT>$50K 69 NO ESCALATION |  | HOVATER C | 1 | 1 | BILL M | 13-014 | ADJ |  |  |  |  |  |  |  |  |  |  |  |  |  |  |  |  |  |  |  |  |  |  |  |  |  |  |  |  |  |  |  |  |  |  |
| 2813221000 |  | Test Magnet System Box Power Supplies w/Dummy Load FY13 | 16d | 2013-09-09 | 2013-09-30 | 3A-23M, 23221024ba FS-194d | 0d |  | 8/5 M-F w/JLAB Holidays ReBaseline | ELEC TECH [104.49 h]; ELEC ENG [52.24 h]; ELEC DES [52.24 h] | 11,285.44 | MERZ B | 1 | 1 | BILL M |  |  | 23221025 | 10-028 | 10-040 | 11-055 | 12-029 | 12-050 | PE | 13-015 | PR | LR13 |  |  |  |  |  |  |  |  |  |  |  |  |  |  |  |  |  |  |  |  |  |  |  |  |
| 2813221005 |  | Test Arc 1 and Hall A PS w/ Dummy Load FY13 | 16d | 2013-09-09 | 2013-09-30 | 23221133 FS-55d, 23221133a FS-55d | 62d | 0d | 8/5 M-F w/JLAB Holidays ReBaseline | ELEC TECH [50.58 h]; ELEC DES [16.52 h]; ELEC ENG [10.32 h] | 3,915.88 | MERZ B | 1 | 1 | BILL M |  |  | 23221135 | 10-028 |  |  | 12-029F |  | PE | 13-015 | PR | LR13 | 12-028 |  |  |  |  |  |  |  |  |  |  |  |  |  |  |  |  |  |  |  |  |  |  |  |
| 2813221000a |  | Test Magnet System Box Power Supplies w/Dummy Load FY14 | 180d | 2013-10-01 | 2014-06-25 | 3A-23M, 2813221000, 23221024ba FS-194d | 0d |  | 8/5 M-F w/JLAB Holidays ReBaseline | ELEC TECH [1175.51 h]; ELEC ENG [587.75 h]; ELEC DES [587.75 h] | 131,004.7 | MERZ B | 1 | 1 | BILL M |  |  | 23221025 | 10-028 | 10-040 | 11-055 | 12-029 | 12-050 | PE | 13-015 | PR | LR13 |  | 14-001 |  |  |  |  |  |  |  |  |  |  |  |  |  |  |  |  |  |  |  |  |  |  |
| 2813221005a |  | Test Arc 1 and Hall A PS w/ Dummy Load FY14 | 46d | 2013-10-01 | 2013-12-05 | 2813221005, 23221133 FS-55d, 23221133a FS-55d | 62d | 44d | 8/5 M-F w/JLAB Holidays ReBaseline | ELEC TECH [145.42 h]; ELEC DES [47.48 h]; ELEC ENG [29.68 h] | 11,616.58 | MERZ B | 1 | 1 | BILL M |  |  | 23221135 | 10-028 |  |  | 12-029F |  | PE | 13-015 | PR | LR13 | 12-028 | 14-001 |  |  |  |  |  |  |  |  |  |  |  |  |  |  |  |  |  |  |  |  |  |  |
|  | 4 | **1.8.1.3.2.2.4 POWER SUPPLY INTEGRATED TESTING** |  | 2013-09-19 | 2014-05-30 |  |  |  |  |  |  |  |  |  |  |  |  |  |  |  |  |  |  |  |  |  |  |  |  |  |  |  |  |  |  |  |  |  |  |  |  |  |  |  |  |  |  |  |  |  |  |
| 2813224000 |  | Integration Testing- Box PS FY13 | 8d | 2013-09-19 | 2013-09-30 | 23224055 FS-35d, 23224055a FS-35d | 18d | 0d | 8/5 M-F w/JLAB Holidays ReBaseline | ELEC ENG [3.76 h]; ELEC DES [7.53 h]; SUPPLIES & MATERIALS; ELEC TECH [22.59 h] | 1,808.73 | MERZ B | 1 | 1 | BILL M |  |  | 23224105 | 10-028 |  |  | 12-029F |  | PE | 13-015 | PR | LR13 | 12-028 |  | PE |  |  |  |  |  |  |  |  |  |  |  |  |  |  |  |  |  |  |  |  |  |
| 2813224000a |  | Integration Testing- Box PS FY14 | 162d | 2013-10-01 | 2014-05-30 | 23224055 FS-35d, 2813224000, 23224055a FS-35d | 18d |  | 8/5 M-F w/JLAB Holidays ReBaseline | ELEC ENG [76.24 h]; ELEC DES [152.47 h]; SUPPLIES & MATERIALS; ELEC TECH [457.41 h] | 37,795.77 | MERZ B | 1 | 1 | BILL M |  |  | 23224105 | 10-028 |  |  | 12-029F |  | PE | 13-015 | PR | LR13 | 12-028 | 14-001 | PE |  |  |  |  |  |  |  |  |  |  |  |  |  |  |  |  |  |  |  |  |  |
| 2813224005 |  | Intergation Testing- Trim PS | 80d | 2013-10-01 | 2014-02-04 | 23224085Aa FS-22d, 23224085A FS-23d | 36d | 0d | 8/5 M-F w/JLAB Holidays ReBaseline | SUPPLIES & MATERIALS; ELEC ENG [40 h]; ELEC TECH [500 h]; ELEC DES [80 h] | 32,135.65 | MERZ B | 1 | 1 | BILL M |  |  | 23224110 | 10-028 |  |  |  |  | PE | 13-015 | PR | LR13 | 12-028 | 14-001 | PE |  |  |  |  |  |  |  |  |  |  |  |  |  |  |  |  |  |  |  |  |  |
|  | 3 | **1.8.1.3.3 CRYOGENICS PRE-OPS CHECKOUT** |  | 2012-10-01 | 2013-08-30 |  |  |  |  |  |  |  |  |  |  |  |  |  |  |  |  |  |  |  |  |  |  |  |  |  |  |  |  |  |  |  |  |  |  |  |  |  |  |  |  |  |  |  |  |  |  |
|  | 1 | **1.8.1.3.3.1 CHL II PRE-OPS CHECKOUT** |  | 2013-01-02 | 2013-08-30 |  |  |  |  |  |  |  |  |  |  |  |  |  |  |  |  |  |  |  |  |  |  |  |  |  |  |  |  |  |  |  |  |  |  |  |  |  |  |  |  |  |  |  |  |  |  |
| 181331000 |  | Cmmssn CHL Helium Plant Revised | 86d | 2013-01-02 | 2013-05-03 | 1331.11000 FS+165d | 146d | 112d |  | MECH TECH [377.6 h]; ELEC ENG [377.6 h]; ELEC TECH [377.6 h]; MECH ENG [566.4 h]; SUPPLIES & MATERIALS | 739,252.85 | ARENIUS D | 1 | 1 | DANA A |  |  |  |  |  |  | 12-029F |  |  |  |  |  |  |  |  | APP | 33111 | 12-018F | 12-032 | 12-040 |  |  |  |  |  |  |  |  |  |  |  |  |  |  |  |  |
| 181331005 |  | Re-Baseline Actuals Adjustment | 1d | 2013-08-30 | 2013-08-30 | 9-130M FS+227d | 20d |  |  | PROCUREMENT>$50K 69 NO ESCALATION | -57,741.53 | ARENIUS D | 1 | 1 | DANA A | 13-014 | ADJ |  |  |  |  |  |  |  |  |  |  |  |  |  |  |  |  |  |  |  |  |  |  |  |  |  |  |  |  |  |  |  |  |  |  |
|  | 2 | **1.8.1.3.3.2 HALL D CRYOGENICS PRE-OPS CHECKOUT** |  | 2012-10-01 | 2013-08-30 |  |  |  |  |  |  |  |  |  |  |  |  |  |  |  |  |  |  |  |  |  |  |  |  |  |  |  |  |  |  |  |  |  |  |  |  |  |  |  |  |  |  |  |  |  |  |
| 181332000 |  | Commission Solenoid Distribution Can (Header) | 10d | 2012-10-01 | 2012-10-12 | 13321050, 13321070 | 28d | 20d |  | MECH ENG [200 h]; SR STAFF [120 h]; MECH DES [80 h]; ELEC TECH [120 h]; MECH TECH [480 h] | 59,918.4 | ARENIUS D | 1 | 1 | DANA A |  |  |  |  |  |  |  |  |  |  |  |  |  |  |  |  |  |  |  | 12-040 | 11-036 |  |  |  |  |  |  |  |  |  |  |  |  |  |  |  |
| 181332005 |  | Re-Baseline Actuals Adjustment | 1d | 2013-08-30 | 2013-08-30 | 9-130M FS+227d | 20d |  |  | PROCUREMENT>$50K 69 NO ESCALATION | -11,463.38 | ARENIUS D | 1 | 1 | DANA A | 13-014 | ADJ |  |  |  |  |  |  |  |  |  |  |  |  |  |  |  |  |  |  |  |  |  |  |  |  |  |  |  |  |  |  |  |  |  |  |
|  | 2 | **1.8.2 HALLS PRE-OPS** |  | 2012-10-01 | 2016-02-10 |  |  |  |  |  |  |  |  |  |  |  |  |  |  |  |  |  |  |  |  |  |  |  |  |  |  |  |  |  |  |  |  |  |  |  |  |  |  |  |  |  |  |  |  |  |  |
|  | 1 | **1.8.2.1 HALL A CHECKOUT AND BEAM COMMISSIONING** |  | 2014-02-28 | 2014-03-04 |  |  |  |  |  |  |  |  |  |  |  |  |  |  |  |  |  |  |  |  |  |  |  |  |  |  |  |  |  |  |  |  |  |  |  |  |  |  |  |  |  |  |  |  |  |  |
|  | X | **1.8.2.1.X HALL A COMMISSIONING WITH BEAM** |  | 2014-02-28 | 2014-03-04 |  |  |  |  |  |  |  |  |  |  |  |  |  |  |  |  |  |  |  |  |  |  |  |  |  |  |  |  |  |  |  |  |  |  |  |  |  |  |  |  |  |  |  |  |  |  |
| 2821X000 |  | H-A PRE-OPS Cmmssn with Beam | 3d | 2014-02-28 | 2014-03-04 | 3P-12M | 19d | 1d | 8/5 M-F w/JLAB Holidays ReBaseline | SCIENTIST [112 h]; VISTNG USERS [84 h]; CONTRB UNIV LBR [168 h]; MECH ENG [28 h] | 12,240.48 | LEROSE J | 1 | 1 | JOHN L |  |  | 2821X000 |  |  |  |  |  | PE | 13-015 | PR |  |  | 14-001 | PE |  |  |  |  | 12-040 |  | Re procurement, there's really nothing to buy | 0 | 0 | 07-024 | 09-012 | 09-028 | 09-028 | 11-026 | 12-025 | NO |  |  |  |  |  |
|  | 2 | **1.8.2.2 HALL B CHECKOUT AND BEAM COMMISSIONING** |  | 2012-10-01 | 2016-02-10 |  |  |  |  |  |  |  |  |  |  |  |  |  |  |  |  |  |  |  |  |  |  |  |  |  |  |  |  |  |  |  |  |  |  |  |  |  |  |  |  |  |  |  |  |  |  |
|  | X | **1.8.2.2.X HALL B COMMISSIONING WITH BEAM** |  | 2016-01-28 | 2016-02-10 |  |  |  |  |  |  |  |  |  |  |  |  |  |  |  |  |  |  |  |  |  |  |  |  |  |  |  |  |  |  |  |  |  |  |  |  |  |  |  |  |  |  |  |  |  |  |
| 2822X000 |  | H-B PRE-OPS Cmmssn with Beam | 10d | 2016-01-28 | 2016-02-10 | 3P-20M | 36d | 0d | 8/5 M-F w/JLAB Holidays ReBaseline | MECH ENG [168 h]; CONTRB UNIV LBR [1008 h]; VISTNG USERS [1344 h]; SCIENTIST [784 h]; MECH TECH [56 h] | 101,808.56 | ELOUADRHIRI L | 1 | 1 | LATIFA E |  |  | 2822X000 |  |  |  |  |  | PE | 13-015 | PR |  |  | 14-001 |  |  |  |  |  | 12-040 |  |  |  |  | 07-024 | 09-012 | 09-028 | 09-028 | 11-026 |  |  | S | 11-038 | 12-024 | 13-002 | 13-010 |

Notes:
- 181331000: Entry Criteria: Ext Pred: Building / BOD / Steps: Vacuum System operational; Controls Checkout Complete; Decontamination Complete; Turbine Installation Complete; 80K Cold Box Cool Down Complete; 4.5K Cold Box Cool Down Complete; Helium Dewar Operational; Cold Box Transfer Line Operational

| ID | WBS | Activity | Duration | Start | Finish | Predecessors | Total float | Free float | Calendar | Resources | Cost | PHAS - Project Phase | RESP - Responsibility | STRT%COMP for CM EVM | FNSH%COMP for CM EVM | CR 08-016 | CAM RESPONSIBLE | CR 09-012 | CR 09-030 Repair | CR 11-026 | CR 12-007 | CR 12-040 | CR 13-002 | CR 13-014 | CR 12-027 | CR 12-054 | CM Drop | ReBaseline Actuals Adjustment | Original Activity ID Rebaseline | EVMS Reporting Codes | BOE Labor | CR 13-015 | Post Rebaseline | CR 14-001 | Pre Rebaseline Remaining Budget | Previously In Progress | BOE Expenses | Temple/Lehman | CR 12-052 | CR 13-010 | CR 11-035 | CR 12-024 | Howard's Code | CR 08-048 | CR 09-022 | CR 09-041 | CR 10-067 | CR 10-069 | CR 11-046 | CR 12-003 | CR 12-012 | CR 12-036 | CR 13-006 | Advance Purchase Plan > 500K | 12 GEV MAJOR PROCUREMENT CATAGORY | CR 10-063 | CR 10-074 |
| --- | --- | --- | --- | --- | --- | --- | --- | --- | --- | --- | --- | --- | --- | --- | --- | --- | --- | --- | --- | --- | --- | --- | --- | --- | --- | --- | --- | --- | --- | --- | --- | --- | --- | --- | --- | --- | --- | --- | --- | --- | --- | --- | --- | --- | --- | --- | --- | --- | --- | --- | --- | --- | --- | --- | --- | --- | --- |
|  | 1 | **1.8.2.2.1 NOT USED** |  |  |  |  |  |  |  |  |  |  |  |  |  |  |  |  |  |  |  |  |  |  |  |  |  |  |  |  |  |  |  |  |  |  |  |  |  |  |  |  |  |  |  |  |  |  |  |  |  |  |  |  |  |  |  |
|  | 2 | **1.8.2.2.2 NOT USED** |  |  |  |  |  |  |  |  |  |  |  |  |  |  |  |  |  |  |  |  |  |  |  |  |  |  |  |  |  |  |  |  |  |  |  |  |  |  |  |  |  |  |  |  |  |  |  |  |  |  |  |  |  |  |  |
|  | 3 | **1.8.2.2.3 HALL B TRIGGER, DAQ AND ONLINE SOFTWARE CHECKOUT** |  | 2012-10-01 | 2015-10-23 |  |  |  |  |  |  |  |  |  |  |  |  |  |  |  |  |  |  |  |  |  |  |  |  |  |  |  |  |  |  |  |  |  |  |  |  |  |  |  |  |  |  |  |  |  |  |  |  |  |  |  |  |
| 18223030 |  | CLAS12 DAQ/online software updates FY13 | 228d | 2012-10-01 | 2013-08-30 | 14232010 | 20d |  |  | SCIENTIST [643.55 h]; VISTNG USERS [1287.1 h]; PD UNIV STUDNT [643.55 h] | 79,651.88 | IN | ELOUADRHIRI L | 1 | 1 | 08-016 | LATIFA E | 09-012 | 09-030 | 11-026 | 12-007 | 12-040 | 13-002F | 13-014 |  |  |  |  |  |  |  |  |  |  |  |  |  |  |  |  |  |  |  |  |  |  |  |  |  |  |  |  |  |  |  |  |  |
| 18223015 |  | TI testing of 52 boards | 169d | 2013-01-02 | 2013-08-30 | 14231075 | 20d |  |  | SCIENTIST [109.04 h] | 7,944.65 | IN | ELOUADRHIRI L | 1 | 1 |  | LATIFA E |  |  |  | 12-007 | 12-040 | 13-002F | 13-014 |  |  |  |  |  |  |  |  |  |  |  |  |  |  |  |  |  |  |  |  |  |  |  |  |  |  |  |  |  |  |  |  |  |
| 18223020 |  | TD testing of 10 boards | 169d | 2013-01-02 | 2013-08-30 | 14231090 | 20d |  |  | SCIENTIST [27.25 h] | 1,985.44 | IN | ELOUADRHIRI L | 1 | 1 |  | LATIFA E |  |  |  | 12-007 | 12-040 | 13-002F | 13-014 |  |  |  |  |  |  |  |  |  |  |  |  |  |  |  |  |  |  |  |  |  |  |  |  |  |  |  |  |  |  |  |  |  |
| 18223025 |  | DAQ Commissioning | 168d | 2013-01-03 | 2013-08-30 | 9-130M FS+60d | 20d |  |  | SCIENTIST [544.13 h] | 39,645.31 |  | ELOUADRHIRI L | 1 | 1 |  | LATIFA E |  |  | 11-026 | 12-007 | 12-040 | 13-002F | 13-014 |  |  |  |  |  |  |  |  |  |  |  |  |  |  |  |  |  |  |  |  |  |  |  |  |  |  |  |  |  |  |  |  |  |
| 18223000 |  | CTP testing of 22 boards | 129d | 2013-03-01 | 2013-08-30 | 14231007, 9-120M | 20d |  |  | SCIENTIST [41.61 h] | 3,031.7 | IN | ELOUADRHIRI L | 1 | 1 | 08-016 | LATIFA E | 09-012 | 09-030 | 11-026 | 12-007 | 12-040 | 13-002F | 13-014 | 12-027 |  |  |  |  |  |  |  |  |  |  |  |  |  |  |  |  |  |  |  |  |  |  |  |  |  |  |  |  |  |  |  |  |
| 18223005 |  | SSP testing of 15 boards | 98d | 2013-04-15 | 2013-08-30 | 14231025 | 20d |  |  | SCIENTIST [15.8 h] | 1,151.19 | IN | ELOUADRHIRI L | 1 | 1 |  | LATIFA E |  |  |  | 12-007 | 12-040 | 13-002F | 13-014 | 12-027 |  |  |  |  |  |  |  |  |  |  |  |  |  |  |  |  |  |  |  |  |  |  |  |  |  |  |  |  |  |  |  |  |
| 18223010 |  | GTP testing of 2 boards | 49d | 2013-06-24 | 2013-08-30 | 14231045 | 20d |  |  | SCIENTIST [7.9 h] | 575.59 | IN | ELOUADRHIRI L | 1 | 1 |  | LATIFA E |  |  |  | 12-007 | 12-040 | 13-002F | 13-014 | 12-027 | 12-054 |  |  |  |  |  |  |  |  |  |  |  |  |  |  |  |  |  |  |  |  |  |  |  |  |  |  |  |  |  |  |  |
| 18223035 |  | Re-Baseline Actuals Adjustment | 1d | 2013-08-30 | 2013-08-30 | 9-130M FS+227d | 20d |  |  | PROCUREMENT>$50K 69 NO ESCALATION | -133,985.75 |  | ELOUADRHIRI L | 1 | 1 |  | LATIFA E |  |  |  |  |  |  | 13-014 |  |  | Y | ADJ |  |  |  |  |  |  |  |  |  |  |  |  |  |  |  |  |  |  |  |  |  |  |  |  |  |  |  |  |  |
| 28223010 |  | GTP testing of 2 boards | 62d | 2014-02-03 | 2014-04-29 | 24231045 | 351d | 310d | 8/5 M-F w/JLAB Holidays ReBaseline | ELEC ENG [80 h]; SCIENTIST [80 h] | 12,024.8 | IN | ELOUADRHIRI L | 1 | 1 |  | LATIFA E |  |  |  | 12-007 | 12-040 | 13-002F |  | 12-027 | 12-054 |  |  | 28223010 | U | PE | 13-015 | PR | 14-001 |  |  |  |  |  |  |  |  |  |  |  |  |  |  |  |  |  |  |  |  |  |  |  |
| 28223025 |  | DAQ Commissioning | 267d | 2014-09-04 | 2015-10-02 | 9-140M FS+228d | 56d | 53d | 8/5 M-F w/JLAB Holidays ReBaseline | SCIENTIST [480 h] | 36,086.4 |  | ELOUADRHIRI L | 1 | 1 |  | LATIFA E |  |  | 11-026 | 12-007 | 12-040 | 13-002F |  |  |  |  |  | 28223025 | S | PE | 13-015 | PR | 14-001 | 26619.1 | Review |  |  |  |  |  |  |  |  |  |  |  |  |  |  |  |  |  |  |  |  |  |
| 28223030 |  | CLAS12 DAQ/online software updates | 267d | 2014-09-04 | 2015-10-02 | 9-140M FS+228d | 56d | 53d | 8/5 M-F w/JLAB Holidays ReBaseline | SCIENTIST [420.56 h]; VISTNG USERS [841.13 h]; PD UNIV STUDNT [420.56 h] | 53,714.13 | IN | ELOUADRHIRI L | 1 | 1 | 08-016 | LATIFA E | 09-012 | 09-030 | 11-026 | 12-007 | 12-040 | 13-002F |  |  |  |  |  | 28223030 | S | PE | 13-015 | PR | 14-001 | 51983.4 | Review |  |  |  |  |  |  |  |  |  |  |  |  |  |  |  |  |  |  |  |  |  |
| 28223000 |  | CTP testing of 22 boards | 64d | 2015-04-29 | 2015-07-30 | 24231007 | 41d | 0d | 8/5 M-F w/JLAB Holidays ReBaseline | SCIENTIST [320 h]; ELEC ENG [320 h] | 48,099.2 | IN | ELOUADRHIRI L | 1 | 1 | 08-016 | LATIFA E | 09-012 | 09-030 | 11-026 | 12-007 | 12-040 | 13-002F |  | 12-027 |  |  |  | 28223000 | U | PE | 13-015 | PR | 14-001 |  |  |  |  |  |  |  |  |  |  |  |  |  |  |  |  |  |  |  |  |  |  |  |
| 28223040 |  | Trigger system commissioning | 60d | 2015-07-31 | 2015-10-23 | 24242057, 28223000, 28223010 | 41d | 38d | 8/5 M-F w/JLAB Holidays ReBaseline | SCIENTIST [640 h]; PLABOR | 129,841.68 | IN | ELOUADRHIRI L | 1 | 1 |  | LATIFA E |  |  |  | 12-007 |  | 13-002F |  | 12-027 | 12-054 |  |  | 24231120 | S | PE | 13-015 | PR | 14-001 |  |  | PE | LR13 |  |  |  |  |  |  |  |  |  |  |  |  |  |  |  |  |  |  |  |
|  | 6 | **1.8.2.2.6 HALL B MAGNET INSTALLATION TESTING** |  | 2015-07-14 | 2015-10-02 |  |  |  |  |  |  |  |  |  |  |  |  |  |  |  |  |  |  |  |  |  |  |  |  |  |  |  |  |  |  |  |  |  |  |  |  |  |  |  |  |  |  |  |  |  |  |  |  |  |  |  |  |
| 28226000 |  | Commission Cryogenic System | 10d | 2015-07-14 | 2015-07-27 | 24264780 | 17d | 0d | 8/5 M-F w/JLAB Holidays ReBaseline | MECH ENG [80 h]; MECH TECH [80 h]; ELEC TECH [80 h] | 13,518.4 |  | ELOUADRHIRI L | 1 | 1 |  | LATIFA E |  |  |  |  |  | 13-002 |  |  |  |  |  | 24264782 | S | PE | 13-015 | PR | 14-001 |  |  |  | LR13 | 12-052 | 13-010 |  |  |  |  |  |  |  |  |  |  |  |  |  |  |  |  |  |
| 28226005 |  | Cooldown | 20d | 2015-07-28 | 2015-08-24 | 24264780, 28226000, 24264555 | 17d | 0d | 8/5 M-F w/JLAB Holidays ReBaseline | MECH TECH [600 h]; MECH ENG [436.8 h]; ELEC ENG [160 h] | 73,028.66 |  | ELOUADRHIRI L | 1 | 1 |  | LATIFA E |  |  |  |  |  | 13-002 |  |  |  |  |  | 24264785 | S | PE | 13-015 | PR | 14-001 |  |  |  | LR13 | 12-052 | 13-010 |  |  |  |  |  |  |  |  |  |  |  |  |  |  |  |  |  |
| 28226020 |  | Solenoid Cool Down | 18d | 2015-08-18 | 2015-09-11 | 24264825 | 3d | 0d | 8/5 M-F w/JLAB Holidays ReBaseline | MECH ENG [72 h]; MECH TECH [72 h] | 8,783.28 |  | ELOUADRHIRI L | 1 | 1 |  | LATIFA E |  |  |  | 12-007 |  | 13-002 |  |  |  |  |  | 24264830 | H | PE | 13-015 | PR | 14-001 |  |  |  | LR13 | 12-052 |  | 11 -035 | 12-024 |  |  |  |  |  |  |  |  |  |  |  |  |  |  |  |
| 28226010 |  | Torus Operational Tests | 10d | 2015-08-25 | 2015-09-08 | 28226005 | 17d | 0d | 8/5 M-F w/JLAB Holidays ReBaseline | MECH TECH [276 h]; MECH ENG [219.2 h]; ELEC ENG [80 h] | 35,438.38 |  | ELOUADRHIRI L | 1 | 1 |  | LATIFA E |  |  |  |  |  | 13-002 |  |  |  |  |  | 24264787 | S | PE | 13-015 | PR | 14-001 |  |  |  | LR13 | 12-052 | 13-010 |  |  |  |  |  |  |  |  |  |  |  |  |  |  |  |  |  |
| 28226015 |  | Map CLAS12 Torus Field both polarities | 16d | 2015-09-09 | 2015-09-30 | 28226010 | 17d | 0d | 8/5 M-F w/JLAB Holidays ReBaseline | MECH TECH [160 h]; CONTRB UNIV LBR [160 h]; SCIENTIST [160 h] | 19,600 |  | ELOUADRHIRI L | 1 | 1 |  | LATIFA E |  |  |  |  |  | 13-002 |  |  |  |  |  | 24264788 | S | PE | 13-015 | PR | 14-001 |  |  |  | LR13 | 12-052 | 13-010 |  |  |  |  |  |  |  |  |  |  |  |  |  |  |  |  |  |
| 28226025 |  | Solenoid Acceptance Tests and Mapping | 15d | 2015-09-14 | 2015-10-02 | 28226020 | 3d | 0d | 8/5 M-F w/JLAB Holidays ReBaseline | MECH TECH [48 h]; MECH ENG [48 h] | 5,855.52 |  | ELOUADRHIRI L | 1 | 1 |  | LATIFA E |  |  |  |  |  | 13-002 |  |  |  |  |  | 24264840 | H | PE | 13-015 | PR | 14-001 |  |  |  | LR13 | 12-052 | 13-010 |  |  |  |  |  |  |  |  |  |  |  |  |  |  |  |  |  |
|  | 3 | **1.8.2.3 HALL C CHECKOUT AND BEAM COMMISSIONING** |  | 2014-07-15 | 2016-02-08 |  |  |  |  |  |  |  |  |  |  |  |  |  |  |  |  |  |  |  |  |  |  |  |  |  |  |  |  |  |  |  |  |  |  |  |  |  |  |  |  |  |  |  |  |  |  |  |  |  |  |  |  |
|  | 1 | **1.8.2.3.1 HALL C HB AND Q1 TESTING** |  | 2014-07-15 | 2014-09-30 |  |  |  |  |  |  |  |  |  |  |  |  |  |  |  |  |  |  |  |  |  |  |  |  |  |  |  |  |  |  |  |  |  |  |  |  |  |  |  |  |  |  |  |  |  |  |  |  |  |  |  |  |
| 28231005 |  | Q1 Cooldown and Acceptance Test | 30d | 2014-07-15 | 2014-08-25 | 2-27M, 24312053M, 24368265, 24368290, 24368185, 24312050c FS-36d | 269d | 0d | 8/5 M-F w/JLAB Holidays ReBaseline | MECH DES [40 h]; MECH ENG [160 h]; MECH TECH [240 h] | 25,356 |  | FENKER H | 1 | 1 |  | HOWARD F | 09-012 |  | 11-026 |  |  |  |  |  | 12-054 |  |  | 24312050a | S | PE | 13-015 | PR | 14-001 |  |  |  | LR13 |  |  |  |  | 5 | 08-048 | 09-022 | 09-041 | 10-067 | 10-069 | 11-046 | 12-003 | 12-012 | 12-036 | 13-006 |  |  |  |  |
| 28231010 |  | Q1 Harmonic Coil Test | 5d | 2014-08-26 | 2014-09-02 | 28231005, 24353015 | 289d | 0d | 8/5 M-F w/JLAB Holidays ReBaseline | MECH TECH [20 h]; MECH ENG [40 h] | 3,933.2 |  | FENKER H | 1 | 1 |  | HOWARD F |  |  | 11-026 |  |  |  |  |  | 12-054 |  |  | 24312050b | H | PE | 13-015 | PR | 14-001 |  |  |  | LR13 |  |  |  |  | 5 |  |  | 09-041 | 10-067 | 10-069 | 11-046 | 12-003 | 12-012 | 12-036 | 13-006 |  |  |  |  |
| 28231000 |  | HB-Acceptance Test | 20d | 2014-09-03 | 2014-09-30 | 2-28M, 24368265, 24368295 | 269d | 0d | 8/5 M-F w/JLAB Holidays ReBaseline | MECH DES [40 h]; MECH ENG [160 h]; MECH TECH [240 h] | 25,356 |  | FENKER H | 1 | 1 | 08-016 | HOWARD F | 09-012 |  | 11-026 |  |  |  |  |  |  |  |  | 24311066 | S | PE | 13-015 | PR | 14-001 |  |  |  | LR13 |  |  |  |  | 5 | 08-048 | 09-022 |  |  | 10-069 | 11-046 |  | 12-012 | 12-036 | 13-006 | APP | 4311 | 10-063 | 10-074 |

| ID | WBS | Activity | Duration | Start | Finish | Predecessors | Total float | Free float | Calendar | Resources | Cost | Original Activity ID Rebaseline | Howard's Code | RESP - Responsibility | STRT%COMP for CM EVM | FNSH%COMP for CM EVM | Advance Purchase Plan > 500K | EVMS Reporting Codes | CAM RESPONSIBLE | CR 09-022 | CR 10-069 | CR 10-076 | CR 11-017 | CR 11-026 | CR 11-046 | CR 12-012 | CR 12-036 | CR 12-054 | CR 13-006 | BOE Procurement | BOE Labor | BOE Expenses | CR 13-015 | Post Rebaseline | Temple/Lehman | CR 14-001 | CR 07-034 | CR 08-048 | 12 GEV MAJOR PROCUREMENT CATAGORY | CR 09-012 | CR 11-025 | CR 07-024 | CR 09-028 | CR 09-028 Repair | CR 11-038 | CR 12-040 | HALL D Related Milestones | CR 09-014 | CR 11-006 | CR 12-021 | CR 13-007 | 12 GeV 3rd level Critical Path | CR 10-042 | CR 11-004 | CR 11-036 | 12 GeV 2nd level Critical Path | CR 13-014 | ReBaseline Actuals Adjustment | Over Under Fixed | CR 08-016 | CR 12-034 | Obligated Prior to Rebaseline |
| --- | --- | --- | --- | --- | --- | --- | --- | --- | --- | --- | --- | --- | --- | --- | --- | --- | --- | --- | --- | --- | --- | --- | --- | --- | --- | --- | --- | --- | --- | --- | --- | --- | --- | --- | --- | --- | --- | --- | --- | --- | --- | --- | --- | --- | --- | --- | --- | --- | --- | --- | --- | --- | --- | --- | --- | --- | --- | --- | --- | --- | --- | --- |
|  | 6 | **1.8.2.3.6 HALL C DIPOLE AND Q2Q3 MAGNET TESTING** |  | 2015-07-02 | 2015-12-23 |  |  |  |  |  |  |  |  |  |  |  |  |  |  |  |  |  |  |  |  |  |  |  |  |  |  |  |  |  |  |  |  |  |  |  |  |  |  |  |  |  |  |  |  |  |  |  |  |  |  |  |  |  |  |  |  |  |
| 28236000 |  | Cool Down Dipole Magnet | 25d | 2015-07-02 | 2015-08-06 | 24368265, 24368185, 24368310, 24368305, 24368315 | 0d |  | 8/5 M-F w/JLAB Holidays ReBaseline | MECH TECH [100 h]; MECH DES [100 h]; MECH ENG [40 h] | 12,848.8 | 24368077 | 5 | FENKER H | 1 | 1 | APP | S | HOWARD F | 09-022 | 10-069 | 10-076 | 11-017 | 11-026 | 11-046 | 12-012 | 12-036 | 12-054 | 13-006 | EJ | PE | EJ | 13-015 | PR | LR13 | 14-001 |  |  |  |  |  |  |  |  |  |  |  |  |  |  |  |  |  |  |  |  |  |  |  |  |  |  |
| 28236010 |  | Q2 Cooldown and Acceptance Test | 30d | 2015-07-23 | 2015-09-02 | 24368325, 24315037ba, 24368185, 24368265, 24368340, 24315037b | 0d |  | 8/5 M-F w/JLAB Holidays ReBaseline | MECH DES [40 h]; MECH ENG [160 h]; MECH TECH [240 h] | 25,356 | 24368495 | 5 | FENKER H | 1 | 1 |  | S | HOWARD F | 09-022 | 10-069 |  | 11-017 | 11-026 | 11-046 | 12-012 | 12-036 |  | 13-006 | PE | PE |  | 13-015 | PR | LR13 | 14-001 | 07-034 | 08-048 | 4313 | 09-012 |  |  |  |  |  |  |  |  |  |  |  |  |  |  |  |  |  |  |  |  |  |  |
| 28236005 |  | Dipole Acceptance Test | 18d | 2015-08-07 | 2015-09-01 | 28236000 | 0d |  | 8/5 M-F w/JLAB Holidays ReBaseline | MECH TECH [80 h]; MECH ENG [80 h] | 9,759.2 | 24368080 | 5 | FENKER H | 1 | 1 |  | H | HOWARD F | 09-022 | 10-069 |  |  | 11-026 | 11-046 | 12-012 | 12-036 | 12-054 | 13-006 | EV | PE |  | 13-015 | PR | LR13 | 14-001 |  |  |  |  | 11-025 |  |  |  |  |  |  |  |  |  |  |  |  |  |  |  |  |  |  |  |  |  |
| 28236015 |  | Q2 HC & FF Test | 5d | 2015-08-27 | 2015-09-02 | 28236010 FS-5d | 42d | 0d | 8/5 M-F w/JLAB Holidays ReBaseline | MECH ENG [80 h]; MECH TECH [56 h] | 8,623.52 | 24368490 | 5 | FENKER H | 1 | 1 |  | H | HOWARD F | 09-022 | 10-069 |  | 11-017 | 11-026 | 11-046 | 12-012 | 12-036 |  | 13-006 | EJ | PE |  | 13-015 | PR | LR13 | 14-001 | 07-034 | 08-048 | 4313 | 09-012 |  |  |  |  |  |  |  |  |  |  |  |  |  |  |  |  |  |  |  |  |  |  |
| 28236020 |  | Q3 Cooldown and Acceptance Test | 37d | 2015-09-11 | 2015-11-02 | 24315037b, 24315037ba, 24368265, 24368360, 24368185, 24368370 | 0d |  | 8/5 M-F w/JLAB Holidays ReBaseline | MECH DES [40 h]; MECH ENG [160 h]; MECH TECH [240 h] | 25,356 | 24368505 | 5 | FENKER H | 1 | 1 |  | S | HOWARD F | 09-022 | 10-069 |  | 11-017 | 11-026 | 11-046 | 12-012 | 12-036 |  | 13-006 |  | PE | EJ | 13-015 | PR | LR13 | 14-001 | 07-034 | 08-048 |  | 09-012 |  |  |  |  |  |  |  |  |  |  |  |  |  |  |  |  |  |  |  |  |  |  |
| 28236025 |  | Q3- HC & FF Test | 5d | 2015-10-27 | 2015-11-02 | 28236020 FS-5d, 243161015 FS-5d | 0d |  | 8/5 M-F w/JLAB Holidays ReBaseline | MECH TECH [56 h]; MECH ENG [80 h] | 8,623.52 | 24368500 | 5 | FENKER H | 1 | 1 |  | H | HOWARD F | 09-022 | 10-069 |  | 11-017 | 11-026 | 11-046 | 12-012 | 12-036 |  | 13-006 | PE | PE |  | 13-015 | PR | LR13 | 14-001 | 07-034 | 08-048 |  |  |  |  |  |  |  |  |  |  |  |  |  |  |  |  |  |  |  |  |  |  |  |  |
| 28236030 |  | Power all Magnets together | 35d | 2015-11-03 | 2015-12-23 | 28231010, 28236010, 24368300, 28231000, 24368390, 28236015, 28236025, 24368335M, 24312051M, 24368280, 24368365 | 0d |  | 8/5 M-F w/JLAB Holidays ReBaseline | ELEC ENG [80 h]; MECH ENG [80 h]; MECH TECH [240 h] | 23,340.8 | 24368155 | 5 | FENKER H | 1 | 1 |  | S | HOWARD F | 09-022 | 10-069 |  | 11-017 | 11-026 | 11-046 | 12-012 | 12-036 |  | 13-006 |  | PE |  | 13-015 | PR | LR13 | 14-001 |  |  |  |  |  |  |  |  |  |  |  |  |  |  |  |  |  |  |  |  |  |  |  |  |  |  |
|  | X | **1.8.2.3.X HALL C COMMISSIONG WITH BEAM** |  | 2016-02-02 | 2016-02-08 |  |  |  |  |  |  |  |  |  |  |  |  |  |  |  |  |  |  |  |  |  |  |  |  |  |  |  |  |  |  |  |  |  |  |  |  |  |  |  |  |  |  |  |  |  |  |  |  |  |  |  |  |  |  |  |  |  |
| 2823X000 |  | H-C PRE-OPS Cmmssn with Beam | 5d | 2016-02-02 | 2016-02-08 | 3P-18M | 38d | 0d | 8/5 M-F w/JLAB Holidays ReBaseline | MECH ENG [84 h]; CONTRB UNIV LBR [504 h]; MECH TECH [28 h]; VISTNG USERS [336 h]; SCIENTIST [392 h] | 43,986.04 | 2823X000 |  | FENKER H | 1 | 1 |  | S | HOWARD F |  |  |  |  | 11-026 |  | 12-012 | 12-036 | 12-054 | 13-006 |  | PE |  | 13-015 | PR |  | 14-001 |  |  |  | 09-012 |  | 07-024 | 09-028 | 09-028 | 11-038 | 12-040 |  |  |  |  |  |  |  |  |  |  |  |  |  |  |  |  |
|  | 4 | **1.8.2.4 HALL D CHECKOUT AND BEAM COMMISSIONING** |  | 2012-10-01 | 2014-12-11 |  |  |  |  |  |  |  |  |  |  |  |  |  |  |  |  |  |  |  |  |  |  |  |  |  |  |  |  |  |  |  |  |  |  |  |  |  |  |  |  |  |  |  |  |  |  |  |  |  |  |  |  |  |  |  |  |  |
|  | X | **1.8.2.4.X HALL D COMMISSIONING WITH BEAM** |  | 2014-11-19 | 2014-12-11 |  |  |  |  |  |  |  |  |  |  |  |  |  |  |  |  |  |  |  |  |  |  |  |  |  |  |  |  |  |  |  |  |  |  |  |  |  |  |  |  |  |  |  |  |  |  |  |  |  |  |  |  |  |  |  |  |  |
| 2824X000 |  | H-D PRE-OPS Cmmssn with Beam | 15d | 2014-11-19 | 2014-12-11 | 3P-16M | 8d | 0d | 8/5 M-F w/JLAB Holidays ReBaseline | MECH ENG [270 h]; CONTRB UNIV LBR [1440 h]; MECH TECH [160 h]; VISTNG USERS [960 h]; SCIENTIST [1440 h] | 155,757.7 | 2824X000 |  | CHUDAKOV | 1 | 1 |  |  | EUGENE C |  |  |  |  | 11-026 |  |  |  |  |  |  | PE |  | 13-015 | PR |  | 14-001 |  |  |  | 09-012 |  | 07-024 | 09-028 | 09-028 | 11-038 | 12-040 | D | 09-014 | 11-006 | 12-021 | 13-007 |  |  |  |  |  |  |  |  |  |  |  |
|  | 1 | **1.8.2.4.1 HALL D SOLENOID COMMISSIONING** |  | 2012-10-01 | 2014-10-06 |  |  |  |  |  |  |  |  |  |  |  |  |  |  |  |  |  |  |  |  |  |  |  |  |  |  |  |  |  |  |  |  |  |  |  |  |  |  |  |  |  |  |  |  |  |  |  |  |  |  |  |  |  |  |  |  |  |
| 18241000 |  | Install cryo/magnet elect/pipe interface | 58d | 2012-10-01 | 2012-12-21 | 9-130M, 151173a, 151173aa | 126d | 35d |  | MECH TECH [544 h] | 24,947.84 |  |  | CHUDAKOV | 1 | 1 |  |  | EUGENE C |  |  |  |  |  |  |  |  |  |  |  |  |  |  |  |  |  |  |  |  |  |  |  |  |  |  | 12-040 | D |  |  | 12-021 |  | 3 |  |  |  |  |  |  |  |  |  |  |
| 18241005 |  | Prepare for Solenoid Readiness review | 49d | 2012-10-12 | 2012-12-21 | 9-130M FS+9d | 126d | 35d |  | MECH ENG [119.2 h] | 8,625.31 |  |  | CHUDAKOV | 1 | 1 |  |  | EUGENE C |  |  |  |  |  |  |  |  |  |  |  |  |  |  |  |  |  |  |  |  |  |  |  |  |  |  | 12-040 | D |  |  | 12-021 |  | 3 |  |  |  |  |  |  |  |  |  |  |
| 18241010 |  | Controls Test (SOLENOID) | 23d | 2012-10-30 | 2012-12-03 | 151080, 151185 FS+21d | 8d | 0d |  | MECH DES [305 h]; SCIENTIST [305 h]; MECH TECH [305 h]; MECH ENG [305 h] | 73,440.95 |  |  | CHUDAKOV | 1 | 1 |  |  | EUGENE C |  |  |  |  |  |  |  |  | 12-054 |  |  |  |  |  |  |  |  |  |  |  |  |  | 07-024 |  |  |  | 12-040 | D | 09-014 | 11-006 |  |  | 3 | 10-042 | 11-004 | 11-036 |  |  |  |  |  |  |  |
| 18241015 |  | Cooldown to 100 K (SOLENOID) | 13d | 2012-11-12 | 2012-11-30 | 3P-24M | 91d | 0d |  | MECH ENG [20 h]; MECH TECH [160 h] | 8,784.8 |  |  | CHUDAKOV | 1 | 1 |  |  | EUGENE C |  |  |  |  |  |  |  |  |  |  |  |  |  |  |  |  |  |  |  |  |  |  | 07-024 |  |  |  | 12-040 | D | 09-014 |  |  |  |  | 10-042 | 11-004 | 11-036 | 2 |  |  |  |  |  |  |
| 18241020 |  | Cooldown to 4 K (SOLENOID) | 7d | 2012-12-03 | 2012-12-11 | 18241015 | 91d | 0d |  | MECH TECH [40 h]; MECH ENG [8 h] | 2,413.28 |  |  | CHUDAKOV | 1 | 1 |  |  | EUGENE C |  |  |  |  |  |  |  |  |  |  |  |  |  |  |  |  |  |  |  |  |  |  | 07-024 |  |  |  | 12-040 | D | 09-014 |  |  |  |  | 10-042 | 11-004 | 11-036 | 2 |  |  |  |  |  |  |
| 18241025 |  | Fill with LHE (SOLENOID) | 7d | 2012-12-13 | 2012-12-21 | 18241020 FS+1d | 91d | 0d |  | MECH ENG [8 h]; MECH TECH [40 h] | 2,413.28 |  |  | CHUDAKOV | 1 | 1 |  |  | EUGENE C |  |  |  |  |  |  |  |  |  |  |  |  |  |  |  |  |  |  |  |  |  |  | 07-024 |  |  |  | 12-040 | D | 09-014 |  |  |  |  | 10-042 | 11-004 | 11-036 | 2 |  |  |  |  |  |  |
| 18241030 |  | Static Test Coils (SOLENOID) | 7d | 2012-12-31 | 2013-01-09 | 18241025 | 91d | 0d |  | MECH ENG [40 h]; MECH TECH [80 h]; PROCUREMENT<$50K 60 | 7,770.53 |  |  | CHUDAKOV | 1 | 1 |  |  | EUGENE C |  |  |  |  |  |  |  |  |  |  |  |  |  |  |  |  |  |  |  |  |  |  | 07-024 |  |  |  | 12-040 | D | 09-014 |  |  |  |  | 10-042 | 11-004 | 11-036 | 2 |  |  |  |  |  |  |
| 18241035 |  | Controls Test Solenoid (SOLENOID) | 12d | 2013-01-10 | 2013-01-28 | 18241030 | 91d | 0d |  | SCIENTIST [960 h]; PROCUREMENT<$50K 60; MECH TECH [480 h]; MECH ENG [480 h] | 127,898.53 |  |  | CHUDAKOV | 1 | 1 |  |  | EUGENE C |  |  |  |  |  |  |  |  |  |  |  |  |  |  |  |  |  |  |  |  |  |  | 07-024 |  |  |  | 12-040 | D | 09-014 | 11-006 |  |  |  | 10-042 | 11-004 | 11-036 | 2 |  |  |  |  |  |  |
| 18241040 |  | Pwr Test Solenoid (SOLENOID) | 16d | 2013-01-29 | 2013-02-20 | 18241035 | 91d | 0d |  | MECH TECH [480 h]; MECH ENG [480 h]; PROCUREMENT<$50K 60 | 57,952.93 |  |  | CHUDAKOV | 1 | 1 |  |  | EUGENE C |  |  |  |  |  |  |  |  |  |  |  |  |  |  |  |  |  |  |  |  |  |  | 07-024 |  |  |  | 12-040 | D | 09-014 |  |  |  |  | 10-042 | 11-004 | 11-036 | 2 |  |  |  |  |  |  |
| 18241050 |  | Re-Baseline Actuals Adjustment | 1d | 2013-08-30 | 2013-08-30 | 9-130M FS+227d | 20d |  |  | PROCUREMENT>$50K 69 NO ESCALATION | 31,366.69 |  |  | CHUDAKOV | 1 | 1 |  |  | EUGENE C |  |  |  |  |  |  |  |  |  |  |  |  |  |  |  |  |  |  |  |  |  |  |  |  |  |  |  |  |  |  |  |  |  |  |  |  |  | 13-014 | ADJ |  |  |  |  |
| 25213030 |  | Consultant Fee (Quench Study WS) | 20d | 2013-09-03 | 2013-09-30 | 9-130M FS+228d | 247d |  | 8/5 M-F w/JLAB Holidays ReBaseline | PROCUREMENT<$50K 60 | 600 | 25213005 |  | CHUDAKOV | 1 | 1 |  | D | EUGENE C |  |  |  |  | 11-026 |  |  |  | 12-054 |  | VQ |  |  | 13-015 | PR |  |  |  |  |  |  |  |  |  |  |  |  | D | 09-014 | 11-006 | 12-021 | 13-007F |  |  |  |  |  |  |  | y | 08-016 | 12-034 | OB |
| 28241000 |  | Maintanence Support Solenoid FY13 | 20d | 2013-09-03 | 2013-09-30 | 9-130M FS+228d, 251250M FS-20d | 54d | 0d | 8/5 M-F w/JLAB Holidays ReBaseline | MECH ENG [11.81 h]; MECH TECH [32.47 h]; SUPPLIES & MATERIALS | 3,539.17 | 251220 |  | CHUDAKOV | 1 | 1 |  | S | EUGENE C |  |  |  |  |  |  |  |  |  |  |  | EJ | EJ | 13-015 | PR |  |  |  |  |  |  |  | 07-024 |  |  |  | 12-040 | D | 09-014 |  |  | 13-007 |  | 10-042 | 11-004 | 11-036 | 2 |  |  |  |  |  |  |
| 28241000a |  | Maintanence Support Solenoid FY14 | 251d | 2013-10-01 | 2014-10-06 | 28241000, 9-130M FS+228d, 251250M FS-20d | 54d | 46d | 8/5 M-F w/JLAB Holidays ReBaseline | MECH ENG [148.19 h]; MECH TECH [407.53 h]; SUPPLIES & MATERIALS | 45,832.79 | 251220 |  | CHUDAKOV | 1 | 1 |  | S | EUGENE C |  |  |  |  |  |  |  |  |  |  |  | EJ | EJ | 13-015 | PR |  | 14-001 |  |  |  |  |  | 07-024 |  |  |  | 12-040 | D | 09-014 |  |  | 13-007 |  | 10-042 | 11-004 | 11-036 | 2 |  |  |  |  |  |  |

Notes:
- 28236005: Caution: Danger !!! PB needs 15 week duration for this / task.

| ID | WBS | Activity | Duration | Start | Finish | Predecessors | Total float | Calendar | Resources | Cost | RESP - Responsibility | STRT%COMP for CM EVM | FNSH%COMP for CM EVM | HALL D Related Milestones | CAM RESPONSIBLE | CR 10-042 | CR 11-006 | CR 11-026 | CR 12-021 | CR 12-040 | CR 12-054 | CR 13-014 | CM Drop | ReBaseline Actuals Adjustment | Original Activity ID Rebaseline | EVMS Reporting Codes | CR 13-007 | BOE Labor | CR 13-015 | Post Rebaseline | CR 14-001 |
| --- | --- | --- | --- | --- | --- | --- | --- | --- | --- | --- | --- | --- | --- | --- | --- | --- | --- | --- | --- | --- | --- | --- | --- | --- | --- | --- | --- | --- | --- | --- | --- |
|  | 3 | **1.8.2.4.3 HALL D ONLINE CHECKOUT** |  | 2013-01-29 | 2014-09-30 |  |  |  |  |  |  |  |  |  |  |  |  |  |  |  |  |  |  |  |  |  |  |  |  |  |  |
|  | 1 | **1.8.2.4.3.1 HALL D DAQ CHECKOUT** |  | 2013-04-22 | 2013-08-30 |  |  |  |  |  |  |  |  |  |  |  |  |  |  |  |  |  |  |  |  |  |  |  |  |  |  |
| 182431000 |  | Check-out Counting House & Equip (DAQ) | 42d | 2013-04-22 | 2013-06-19 | 1531110 FS-21d | 71d |  | COMP SCIENT [320 h]; SCIENTIST [120 h] | 30,410.4 | CHUDAKOV | 1 | 1 | D | EUGENE C | 10-042 | 11-006 | 11-026 | 12-021 | 12-040 | 12-054 |  |  |  |  |  |  |  |  |  |  |
| 182431010 |  | Check-out DAQ Electrnc's (DAQ) | 72d | 2013-05-21 | 2013-08-30 | 1531110 | 20d |  | SCIENTIST [308.57 h] | 22,482.41 | CHUDAKOV | 1 | 1 | D | EUGENE C | 10-042 | 11-006 | 11-026 | 12-021 | 12-040 | 12-054 | 13-014 |  |  |  |  |  |  |  |  |  |
| 182431015 |  | Re-Baseline Actuals Adjustment | 1d | 2013-08-30 | 2013-08-30 | 9-130M FS+227d | 20d |  | PROCUREMENT>$50K 69 NO ESCALATION | -52,892.81 | CHUDAKOV | 1 | 1 |  | EUGENE C |  |  |  |  |  |  | 13-014 | Y | ADJ |  |  |  |  |  |  |  |
|  | 2 | **1.8.2.4.3.2 HALL D SOFTWARE CHECKOUT** |  | 2013-01-29 | 2014-09-30 |  |  |  |  |  |  |  |  |  |  |  |  |  |  |  |  |  |  |  |  |  |  |  |  |  |  |
| 182432050 |  | Check-out Experiment Control Software HV | 151d | 2013-01-29 | 2013-08-30 | 1532105da | 20d |  | SCIENTIST [87.85 h] | 6,400.75 | CHUDAKOV | 1 | 1 | D | EUGENE C |  | 11-006 | 11-026 | 12-021 | 12-040 |  | 13-014 |  |  |  |  |  |  |  |  |  |
| 182432055 |  | Check-out Experiment Control Software LV | 151d | 2013-01-29 | 2013-08-30 | 1532105fa | 20d |  | SCIENTIST [65.89 h] | 4,800.75 | CHUDAKOV | 1 | 1 | D | EUGENE C |  | 11-006 | 11-026 | 12-021 | 12-040 |  | 13-014 |  |  |  |  |  |  |  |  |  |
| 182432020 |  | Check-out Event Displays | 138d | 2013-02-15 | 2013-08-30 | 1532095a | 20d |  | SCIENTIST [120.43 h]; CONTRB UNIV LBR [125.46 h] | 8,774.82 | CHUDAKOV | 1 | 1 | D | EUGENE C |  | 11-006 | 11-026 | 12-021 | 12-040 |  | 13-014 |  |  |  |  |  |  |  |  |  |
| 182432060 |  | Check-out Experiment Control Software Motors | 135d | 2013-02-21 | 2013-08-30 | 1532105ga | 20d |  | SCIENTIST [78.54 h] | 5,722.42 | CHUDAKOV | 1 | 1 | D | EUGENE C |  | 11-006 | 11-026 | 12-021 | 12-040 |  | 13-014 |  |  |  |  |  |  |  |  |  |
| 182432080 |  | Check-out Experiment Control Software DAQ Interface | 135d | 2013-02-21 | 2013-08-30 | 1532105na | 20d |  | SCIENTIST [39.27 h] | 2,861.21 | CHUDAKOV | 1 | 1 | D | EUGENE C |  | 11-006 | 11-026 | 12-021 | 12-040 |  | 13-014 |  |  |  |  |  |  |  |  |  |
| 182432000 |  | Check-out Front-End Software | 128d | 2013-03-04 | 2013-08-30 | 1532070 FS-100d | 20d |  | SCIENTIST [223.42 h] | 16,278.38 | CHUDAKOV | 1 | 1 | D | EUGENE C |  | 11-006 | 11-026 | 12-021 | 12-040 |  | 13-014 |  |  |  |  |  |  |  |  |  |
| 182432075 |  | Check-out Experiment Control Software Target | 122d | 2013-03-12 | 2013-08-30 | 1532105k FS-100d | 20d |  | SCIENTIST [70.98 h] | 5,171.6 | CHUDAKOV | 1 | 1 | D | EUGENE C |  | 11-006 | 11-026 | 12-021 | 12-040 |  | 13-014 |  |  |  |  |  |  |  |  |  |
| 182432030 |  | Check-out Experiment Control Software Framework | 107d | 2013-04-02 | 2013-08-30 | 1531165, 1531227a, 1531195, 1531225, 1532105s, 1531150 FS-20d, 1531227 | 20d |  | SCIENTIST [62.25 h] | 4,535.54 | CHUDAKOV | 1 | 1 | D | EUGENE C |  | 11-006 | 11-026 | 12-021 | 12-040 |  | 13-014 |  |  |  |  |  |  |  |  |  |
| 182432040 |  | Check-out Experiment Control Software Backup/Restore | 105d | 2013-04-04 | 2013-08-30 | 1532105b FS-40d | 20d |  | SCIENTIST [61.09 h] | 4,451.02 | CHUDAKOV | 1 | 1 | D | EUGENE C |  | 11-006 | 11-026 | 12-021 | 12-040 |  | 13-014 |  |  |  |  |  |  |  |  |  |
| 182432015 |  | Check-out Archiving Sys | 102d | 2013-04-09 | 2013-08-30 | 1532090a FS-100d, 1532090b FS-100d, 1532090 FS-60d | 20d |  | SCIENTIST [178.04 h] | 12,971.99 | CHUDAKOV | 1 | 1 | D | EUGENE C |  | 11-006 | 11-026 | 12-021 | 12-040 |  | 13-014 |  |  |  |  |  |  |  |  |  |
| 182432025 |  | Check-out Storage Mngmnt Software | 102d | 2013-04-09 | 2013-08-30 | 1532100 FS-100d | 20d |  | SCIENTIST [59.34 h]; COMP SCIENT [103.86 h] | 11,355.89 | CHUDAKOV | 1 | 1 | D | EUGENE C |  | 11-006 | 11-026 | 12-021 | 12-040 |  | 13-014 |  |  |  |  |  |  |  |  |  |
| 182432045 |  | Check-out Experiment Control Software Magnet PS | 102d | 2013-04-09 | 2013-08-30 | 1532105c FS-100d | 20d |  | SCIENTIST [59.34 h] | 4,323.51 | CHUDAKOV | 1 | 1 | D | EUGENE C |  | 11-006 | 11-026 | 12-021 | 12-040 |  | 13-014 |  |  |  |  |  |  |  |  |  |
| 182432065 |  | Check-out Experiment Control Software Gas Systems | 102d | 2013-04-09 | 2013-08-30 | 1532105h FS-100d | 20d |  | SCIENTIST [44.51 h] | 3,243 | CHUDAKOV | 1 | 1 | D | EUGENE C |  | 11-006 | 11-026 | 12-021 | 12-040 |  | 13-014 |  |  |  |  |  |  |  |  |  |
| 182432070 |  | Check-out Experiment Control Software Temperature | 102d | 2013-04-09 | 2013-08-30 | 1532105j FS-100d | 20d |  | SCIENTIST [59.34 h] | 4,323.51 | CHUDAKOV | 1 | 1 | D | EUGENE C |  | 11-006 | 11-026 | 12-021 | 12-040 |  | 13-014 |  |  |  |  |  |  |  |  |  |
| 182432085 |  | Level 1 Trigger Expert Software | 101d | 2013-04-10 | 2013-08-30 | 9-130M FS+127d | 20d |  | SCIENTIST [146.91 h]; COMP SCIENT [14.69 h] | 11,698.52 | CHUDAKOV | 1 | 1 | D | EUGENE C |  | 11-006 | 11-026 | 12-021 | 12-040 |  |  |  |  |  |  |  |  |  |  |  |
| 182432035 |  | Check-out Experiment Control Software Display Manegement | 97d | 2013-04-16 | 2013-08-30 | 1532105a | 20d |  | SCIENTIST [56.43 h] | 4,111.49 | CHUDAKOV | 1 | 1 | D | EUGENE C |  | 11-006 | 11-026 | 12-021 | 12-040 |  | 13-014 |  |  |  |  |  |  |  |  |  |
| 182432010 |  | Check-out Alarm Sys | 33d | 2013-07-17 | 2013-08-30 | 1532085 FS-20d | 20d |  | SCIENTIST [81.23 h] | 5,918.42 | CHUDAKOV | 1 | 1 | D | EUGENE C |  | 11-006 | 11-026 | 12-021 | 12-040 | 12-054 | 13-014 |  |  |  |  |  |  |  |  |  |
| 182432005 |  | Check-out Monitoring | 22d | 2013-08-01 | 2013-08-30 | 1532080ba FS-200d, 1532080f FS-200d, 1532082 FS-22d, 1532080c FS-100d, 1532080da FS-200d, 1532080a FS-190d, 1532080g FS-22d, 1532080 | 20d |  | SCIENTIST [109.84 h] | 8,002.94 | CHUDAKOV | 1 | 1 | D | EUGENE C |  | 11-006 | 11-026 | 12-021 | 12-040 | 12-054 | 13-014 |  |  |  |  |  |  |  |  |  |
| 182432090 |  | Re-Baseline Actuals Adjustment | 1d | 2013-08-30 | 2013-08-30 | 9-130M FS+227d | 20d |  | PROCUREMENT>$50K 69 NO ESCALATION | -124,945.8 | CHUDAKOV | 1 | 1 |  | EUGENE C |  |  |  |  |  |  | 13-014 |  | ADJ |  |  |  |  |  |  |  |
| 282432010 |  | Check-out Alarm Sys | 128d | 2013-11-20 | 2014-06-03 | 2532230 FS+11d, 2532230a FS+11d | 83d | 8/5 M-F w/JLAB Holidays ReBaseline | VISTNG USERS [80 h]; SCIENTIST [40 h] | 4,654.4 | CHUDAKOV | 1 | 1 | D | EUGENE C |  | 11-006 | 11-026 | 12-021 | 12-040 | 12-054 |  |  |  | 282432010 | U | 13-007 | EJ | 13-015 | PR | 14-001 |
| 282432005 |  | Check-out Monitoring | 106d | 2014-03-07 | 2014-08-05 | 2532080 FS+22d, 2532080a FS+22d | 39d | 8/5 M-F w/JLAB Holidays ReBaseline | VISTNG USERS [80 h]; SCIENTIST [80 h] | 7,661.6 | CHUDAKOV | 1 | 1 | D | EUGENE C |  | 11-006 | 11-026 | 12-021 | 12-040 | 12-054 |  |  |  | 282432005 | U | 13-007 | EJ | 13-015 | PR | 14-001 |
| 282432015 |  | Check-out Archiving Sys | 128d | 2014-04-01 | 2014-09-30 | 2532250a, 2532250 | 0d | 8/5 M-F w/JLAB Holidays ReBaseline | VISTNG USERS [80 h]; SCIENTIST [80 h] | 7,661.6 | CHUDAKOV | 1 | 1 | D | EUGENE C |  | 11-006 | 11-026 | 12-021 | 12-040 |  |  |  |  | 282432015 | U | 13-007 | EJ | 13-015 | PR | 14-001 |
| 282432025 |  | Check-out Storage Mngmnt Software | 58d | 2014-07-08 | 2014-09-26 | 2532100 FS+78d | 2d | 8/5 M-F w/JLAB Holidays ReBaseline | SR STAFF [80 h]; SCIENTIST [40 h] | 12,632.8 | CHUDAKOV | 1 | 1 | D | EUGENE C |  | 11-006 | 11-026 | 12-021 | 12-040 |  |  |  |  | 282432025 | U | 13-007 | EJ | 13-015 | PR | 14-001 |

| ID | WBS | Activity | Duration | Start | Finish | Predecessors | Total float | Free float | Calendar | Resources | Cost | RESP - Responsibility | STRT%COMP for CM EVM | FNSH%COMP for CM EVM | HALL D Related Milestones | CR 07-024 | CR 07-027 | CAM RESPONSIBLE | CR 11-006 | CR 11-026 | CR 11-049 | CR 12-021 | CR 12-040 | CR 12-053 | CR 13-014 | CR 09-012 | Duplications | ReBaseline Actuals Adjustment | Original Activity ID Rebaseline | EVMS Reporting Codes | BOE Labor | CR 13-015 | Post Rebaseline | CR 14-001 | CR 12-054 | CR 13-007 |
| --- | --- | --- | --- | --- | --- | --- | --- | --- | --- | --- | --- | --- | --- | --- | --- | --- | --- | --- | --- | --- | --- | --- | --- | --- | --- | --- | --- | --- | --- | --- | --- | --- | --- | --- | --- | --- |
|  | 4 | **1.8.2.4.4 HALL D TRIGGER AND ELECTRONICS CHECKOUT** |  | 2012-10-01 | 2014-09-30 |  |  |  |  |  |  |  |  |  |  |  |  |  |  |  |  |  |  |  |  |  |  |  |  |  |  |  |  |  |  |  |
|  | 3 | **1.8.2.4.4.3 HALL D TRIGGER BOARDS ACCEPTANCE TESTING** |  | 2012-10-01 | 2014-09-30 |  |  |  |  |  |  |  |  |  |  |  |  |  |  |  |  |  |  |  |  |  |  |  |  |  |  |  |  |  |  |  |
| 182443005 |  | Acceptance test of TI boards (FE grp) FY13 | 72d | 2012-10-01 | 2013-01-18 | 1543045 | 111d | 91d |  | ELEC ENG [155.68 h] | 11,335.06 | CHUDAKOV | 1 | 1 | D | 07-024 | 07-027 | EUGENE C | 11-006 | 11-026 | 11-049 | 12-021 | 12-040 | 12-053 |  |  |  |  |  |  |  |  |  |  |  |  |
| 182443025 |  | Trigger Calibration (Hall D grp) | 228d | 2012-10-01 | 2013-08-30 | 1543130, 9-120M FS+120d, 1543140a, 1543135 | 20d |  |  | ELEC ENG [157.7 h]; SCIENTIST [210.25 h] | 26,800.95 | CHUDAKOV | 1 | 1 | D | 07-024 | 07-027 | EUGENE C | 11-006 | 11-026 |  | 12-021 | 12-040 |  | 13-014 |  |  |  |  |  |  |  |  |  |  |  |
| 182443010 |  | Acceptance test of CTP boards (FE grp) | 98d | 2013-01-10 | 2013-05-30 | 1543025 FS-55d | 20d | 0d |  | ELEC ENG [320 h] | 23,299.2 | CHUDAKOV | 1 | 1 | D | 07-024 | 07-027 | EUGENE C | 11-006 | 11-026 | 11-049 | 12-021 | 12-040 |  |  | 09-012 |  |  |  |  |  |  |  |  |  |  |
| 182443015 |  | Acceptance test of SSP boards (FE grp) | 98d | 2013-01-10 | 2013-05-30 | 1543070 FS-55d | 20d | 0d |  | ELEC ENG [320 h] | 23,299.2 | CHUDAKOV | 1 | 1 | D |  |  | EUGENE C | 11-006 | 11-026 | 11-049 | 12-021 | 12-040 |  |  |  |  |  |  |  |  |  |  |  |  |  |
| 182443000 |  | Acceptance test of TS board (FE grp) | 106d | 2013-03-01 | 2013-07-30 | 1543020 FS-65d | 128d | 108d |  | ELEC ENG [240 h] | 17,474.4 | CHUDAKOV | 1 | 1 | D | 07-024 |  | EUGENE C | 11-006 | 11-026 |  | 12-021 | 12-040 |  |  | 09-012 | DUP |  |  |  |  |  |  |  |  |  |
| 182443020 |  | Acceptance test of GTP boards (FE grp) | 57d | 2013-05-09 | 2013-07-30 | 1543085 FS-15d, 1543085a FS-15d | 43d |  |  | ELEC ENG [280 h] | 20,386.8 | CHUDAKOV | 1 | 1 | D | 07-024 | 07-027 | EUGENE C | 11-006 | 11-026 | 11-049 | 12-021 | 12-040 |  |  |  |  |  |  |  |  |  |  |  |  |  |
| 182443030 |  | Re-Baseline Actuals Adjustment | 1d | 2013-08-30 | 2013-08-30 | 9-130M FS+227d | 20d |  |  | PROCUREMENT>$50K 69 NO ESCALATION | -62,736.65 | CHUDAKOV | 1 | 1 |  |  |  | EUGENE C |  |  |  |  |  |  | 13-014 |  |  | ADJ |  |  |  |  |  |  |  |  |
| 282443010 |  | Acceptance test of CTP boards (FE grp) FY13 | 20d | 2013-09-03 | 2013-09-30 | 2543025 FS-20d, 2543030 FS-20d | 214d | 0d | 8/5 M-F w/JLAB Holidays ReBaseline | ELEC ENG [182.59 h] | 13,294.38 | CHUDAKOV | 1 | 1 | D | 07-024 | 07-027 | EUGENE C | 11-006 | 11-026 | 11-049 | 12-021 | 12-040 |  |  | 09-012 |  |  | 282443010 | U | EJ | 13-015 | PR |  |  |  |
| 282443020 |  | Acceptance test of GTP boards (FE grp) FY13 | 20d | 2013-09-03 | 2013-09-30 | 9-130M FS+228d | 151d | 0d | 8/5 M-F w/JLAB Holidays ReBaseline | ELEC ENG [98.25 h] | 7,153.58 | CHUDAKOV | 1 | 1 | D | 07-024 | 07-027 | EUGENE C | 11-006 | 11-026 | 11-049 | 12-021 | 12-040 |  |  |  |  |  | 282443020 | U | EJ | 13-015 | PR |  |  |  |
| 282443025a5 |  | Acceptance test of TS boards (FE_grp) FY13 | 20d | 2013-09-03 | 2013-09-30 | 9-130M FS+228d, 2543155 FS-286d | 232d | 0d | 8/5 M-F w/JLAB Holidays ReBaseline | ELEC ENG [45.71 h] | 3,328.15 | CHUDAKOV | 1 | 1 | D | 07-024 | 07-027 | EUGENE C | 11-006 | 11-026 |  | 12-021 | 12-040 |  |  |  |  |  | 282443025a5 | U | EJ | 13-015 | PR |  |  |  |
| 282443010a |  | Acceptance test of CTP boards (FE grp) FY14 | 14d | 2013-10-01 | 2013-10-18 | 282443010, 2543025 FS-20d, 2543030 FS-20d | 214d | 86d | 8/5 M-F w/JLAB Holidays ReBaseline | ELEC ENG [127.81 h] | 9,602.37 | CHUDAKOV | 1 | 1 | D | 07-024 | 07-027 | EUGENE C | 11-006 | 11-026 | 11-049 | 12-021 | 12-040 |  |  | 09-012 |  |  | 282443010 | U | EJ | 13-015 | PR | 14-001 |  |  |
| 282443020a |  | Acceptance test of GTP boards (FE grp) FY14 | 37d | 2013-10-01 | 2013-11-20 | 9-130M FS+228d, 282443020 | 151d | 23d | 8/5 M-F w/JLAB Holidays ReBaseline | ELEC ENG [181.75 h] | 13,654.88 | CHUDAKOV | 1 | 1 | D | 07-024 | 07-027 | EUGENE C | 11-006 | 11-026 | 11-049 | 12-021 | 12-040 |  |  |  |  |  | 282443020 | U | EJ | 13-015 | PR | 14-001 |  |  |
| 282443025a5a |  | Acceptance test of TS boards (FE_grp) FY14 | 15d | 2013-10-01 | 2013-10-21 | 282443025a5, 9-130M FS+228d, 2543155 FS-286d | 232d |  | 8/5 M-F w/JLAB Holidays ReBaseline | ELEC ENG [34.29 h] | 2,576.21 | CHUDAKOV | 1 | 1 | D | 07-024 | 07-027 | EUGENE C | 11-006 | 11-026 |  | 12-021 | 12-040 |  |  |  |  |  | 282443025a5 | U | EJ | 13-015 | PR | 14-001 |  |  |
| 282443025a |  | Trigger Calibration (Hall D grp) | 184d | 2014-01-10 | 2014-09-30 | 9-140M FS+63d | 0d |  | 8/5 M-F w/JLAB Holidays ReBaseline | SCIENTIST [280 h] | 21,050.4 | CHUDAKOV | 1 | 1 | D | 07-024 | 07-027 | EUGENE C | 11-006 | 11-026 |  | 12-021 | 12-040 |  |  |  |  |  | 282443025a | S | EJ | 13-015 | PR | 14-001 |  |  |
|  | 6 | **1.8.2.4.4.6 HALL D DETECTOR ELECTRONICS BOARDS CHECKOUT** |  | 2012-10-01 | 2013-11-21 |  |  |  |  |  |  |  |  |  |  |  |  |  |  |  |  |  |  |  |  |  |  |  |  |  |  |  |  |  |  |  |
| 182446000 |  | Test Power Distribution FY13 | 10d | 2012-10-01 | 2012-10-12 | 1546380 | 213d | 0d |  | ELEC ENG [33.1 h] | 2,410.01 | CHUDAKOV | 1 | 1 | D |  |  | EUGENE C | 11-006 | 11-026 |  | 12-021 | 12-040 | 12-053 |  |  |  |  |  |  |  |  |  |  |  |  |
| 182446005 |  | Test BCAL Readout System | 30d | 2012-10-08 | 2012-11-16 | 182446000 FS-5d, 1546330 | 213d |  |  | ELEC TECH [136 h]; ELEC ENG [28 h] | 8,232.12 | CHUDAKOV | 1 | 1 | D |  |  | EUGENE C | 11-006 | 11-026 |  | 12-021 | 12-040 |  |  |  |  |  |  |  |  |  |  |  |  |  |
| 182446015 |  | Test Pair Spectrometer Transition Board | 30d | 2012-11-05 | 2012-12-18 | 1546430 FS+25d | 170d | 19d |  | ELEC TECH [34 h] | 1,548.36 | CHUDAKOV | 1 | 1 | D |  |  | EUGENE C | 11-006 | 11-026 |  | 12-021 | 12-040 | 12-053 |  |  |  |  |  |  |  |  |  |  | 12-054 |  |
| 182446020 |  | Test Pair Spectrometer Power Distribution | 30d | 2012-11-19 | 2013-01-09 | 1546435 FS+35d | 160d | 9d |  | ELEC TECH [34 h] | 1,548.36 | CHUDAKOV | 1 | 1 | D |  |  | EUGENE C | 11-006 | 11-026 |  | 12-021 | 12-040 | 12-053 |  |  |  |  |  |  |  |  |  |  | 12-054 |  |
| 182446010 |  | Test Pair Spectrometer PS Readout Board | 29d | 2012-12-05 | 2013-01-23 | 9-130M FS+45d, 1546425 | 151d | 0d |  | ELEC TECH [68 h]; ELEC ENG [34 h] | 5,572.26 | CHUDAKOV | 1 | 1 | D |  |  | EUGENE C | 11-006 | 11-026 |  | 12-021 | 12-040 | 12-053 |  |  |  |  |  |  |  |  |  |  | 12-054 |  |
| 182446025 |  | Test Pair Spectrometer System | 23d | 2013-01-24 | 2013-02-26 | 1546440 FS-13d, 182446010, 182446020, 182446015 | 151d |  |  | ELEC ENG [34 h]; ELEC TECH [68 h] | 5,572.26 | CHUDAKOV | 1 | 1 | D |  |  | EUGENE C | 11-006 | 11-026 |  | 12-021 | 12-040 |  |  |  |  |  |  |  |  |  |  |  | 12-054 |  |
| 182446030 |  | Test Start Counter Readout Board | 24d | 2013-05-13 | 2013-06-14 | 1546525 FS-14d | 74d |  |  | ELEC ENG [34 h]; ELEC TECH [68 h] | 5,572.26 | CHUDAKOV | 1 | 1 | D |  |  | EUGENE C | 11-006 | 11-026 |  | 12-021 | 12-040 |  |  |  |  |  |  |  |  |  |  |  |  |  |
| 182446035 |  | Test Start Counter Transition Board | 24d | 2013-05-20 | 2013-06-21 | 1546530 FS+13d | 69d |  |  | ELEC TECH [34 h] | 1,548.36 | CHUDAKOV | 1 | 1 | D |  |  | EUGENE C | 11-006 | 11-026 |  | 12-021 | 12-040 |  |  |  |  |  |  |  |  |  |  |  |  |  |
| 182446040 |  | Test Start Counter Power Distribution | 29d | 2013-06-10 | 2013-07-19 | 1546535 FS+5d | 50d |  |  | ELEC TECH [34 h] | 1,548.36 | CHUDAKOV | 1 | 1 | D |  |  | EUGENE C | 11-006 | 11-026 |  | 12-021 | 12-040 |  |  |  |  |  |  |  |  |  |  |  |  |  |
| 182446045 |  | Re-Baseline Actuals Adjustment | 1d | 2013-08-30 | 2013-08-30 | 9-130M FS+227d | 20d |  |  | PROCUREMENT>$50K 69 NO ESCALATION | -33,552.35 | CHUDAKOV | 1 | 1 |  |  |  | EUGENE C |  |  |  |  |  |  | 13-014 |  |  | ADJ |  |  |  |  |  |  |  |  |
| 282446000 |  | Test Power Distribution FY13 | 16d | 2013-09-09 | 2013-09-30 | 9-130M FS+232d | 213d | 0d | 8/5 M-F w/JLAB Holidays ReBaseline | ELEC ENG [12.8 h]; ELEC TECH [25.6 h] | 2,097.79 | CHUDAKOV | 1 | 1 | D |  |  | EUGENE C | 11-006 | 11-026 |  | 12-021 | 12-040 | 12-053 |  |  |  |  | 282446000 | U | PE | 13-015 | PR |  |  | 13-007F |
| 282446030 |  | Test Start Counter Readout Board FY13 | 16d | 2013-09-09 | 2013-09-30 | 9-130M FS+232d | 199d | 0d | 8/5 M-F w/JLAB Holidays ReBaseline | ELEC ENG [11.85 h]; ELEC TECH [23.71 h] | 1,942.64 | CHUDAKOV | 1 | 1 | D |  |  | EUGENE C | 11-006 | 11-026 |  | 12-021 | 12-040 |  |  |  |  |  | 282446030 | U | PE | 13-015 | PR |  |  |  |
| 282446035 |  | Test Start Counter Transition Board FY13 | 16d | 2013-09-09 | 2013-09-30 | 9-130M FS+232d | 228d | 0d | 8/5 M-F w/JLAB Holidays ReBaseline | ELEC TECH [21.76 h] | 990.95 | CHUDAKOV | 1 | 1 | D |  |  | EUGENE C | 11-006 | 11-026 |  | 12-021 | 12-040 |  |  |  |  |  | 282446035 | U | PE | 13-015 | PR |  |  |  |
| 282446040 |  | Test Start Counter Power Distribution FY13 | 16d | 2013-09-09 | 2013-09-30 | 9-130M FS+232d | 213d | 0d | 8/5 M-F w/JLAB Holidays ReBaseline | ELEC TECH [13.6 h] | 619.34 | CHUDAKOV | 1 | 1 | D |  |  | EUGENE C | 11-006 | 11-026 |  | 12-021 | 12-040 |  |  |  |  |  | 282446040 | U | PE | 13-015 | PR |  |  |  |
| 282446000a |  | Test Power Distribution FY14 | 34d | 2013-10-01 | 2013-11-15 | 9-130M FS+232d, 282446000 | 213d |  | 8/5 M-F w/JLAB Holidays ReBaseline | ELEC ENG [27.2 h]; ELEC TECH [54.4 h] | 4,599.8 | CHUDAKOV | 1 | 1 | D |  |  | EUGENE C | 11-006 | 11-026 |  | 12-021 | 12-040 | 12-053 |  |  |  |  | 282446000 | U | PE | 13-015 | PR | 14-001 |  | 13-007F |
| 282446030a |  | Test Start Counter Readout Board FY14 | 38d | 2013-10-01 | 2013-11-21 | 282446030, 9-130M FS+232d | 199d | 188d | 8/5 M-F w/JLAB Holidays ReBaseline | ELEC ENG [28.15 h]; ELEC TECH [56.29 h] | 4,759.88 | CHUDAKOV | 1 | 1 | D |  |  | EUGENE C | 11-006 | 11-026 |  | 12-021 | 12-040 |  |  |  |  |  | 282446030 | U | PE | 13-015 | PR | 14-001 |  |  |
| 282446035a |  | Test Start Counter Transition Board FY14 | 9d | 2013-10-01 | 2013-10-11 | 9-130M FS+232d, 282446035 | 228d | 217d | 8/5 M-F w/JLAB Holidays ReBaseline | ELEC TECH [12.24 h] | 575.16 | CHUDAKOV | 1 | 1 | D |  |  | EUGENE C | 11-006 | 11-026 |  | 12-021 | 12-040 |  |  |  |  |  | 282446035 | U | PE | 13-015 | PR | 14-001 |  |  |
| 282446040a |  | Test Start Counter Power Distribution FY14 | 24d | 2013-10-01 | 2013-11-01 | 9-130M FS+232d, 282446040 | 213d | 202d | 8/5 M-F w/JLAB Holidays ReBaseline | ELEC TECH [20.4 h] | 958.6 | CHUDAKOV | 1 | 1 | D |  |  | EUGENE C | 11-006 | 11-026 |  | 12-021 | 12-040 |  |  |  |  |  | 282446040 | U | PE | 13-015 | PR | 14-001 |  |  |
| 282446010 |  | Test Pair Spectrometer PS Readout Board | 34d | 2013-10-07 | 2013-11-21 | 2546425 FS+4d | 199d | 0d | 8/5 M-F w/JLAB Holidays ReBaseline | ELEC TECH [80 h]; ELEC ENG [40 h] | 6,764.4 | CHUDAKOV | 1 | 1 | D |  |  | EUGENE C | 11-006 | 11-026 |  | 12-021 | 12-040 | 12-053 |  |  |  |  | 282446010 | U | PE | 13-015 | PR | 14-001 | 12-054 |  |
| 282446015a |  | Test Pair Spectrometer Transition Board | 34d | 2013-10-07 | 2013-11-21 | 2546430 FS+4d | 199d | 0d | 8/5 M-F w/JLAB Holidays ReBaseline | ELEC TECH [40 h] | 1,879.6 | CHUDAKOV | 1 | 1 | D |  |  | EUGENE C | 11-006 | 11-026 |  | 12-021 | 12-040 | 12-053 |  |  |  |  | 282446015a | U | PE | 13-015 | PR | 14-001 | 12-054 |  |
| 282446020 |  | Test Pair Spectrometer Power Distribution | 34d | 2013-10-07 | 2013-11-21 | 2546435 FS+4d | 199d | 0d | 8/5 M-F w/JLAB Holidays ReBaseline | ELEC TECH [40 h] | 1,879.6 | CHUDAKOV | 1 | 1 | D |  |  | EUGENE C | 11-006 | 11-026 |  | 12-021 | 12-040 | 12-053 |  |  |  |  | 282446020 | U | PE | 13-015 | PR | 14-001 | 12-054 |  |
| 282446025 |  | Test Pair Spectrometer System | 34d | 2013-10-07 | 2013-11-21 | 282446015a FS-34d, 282446020 FS-34d, 282446010 FS-34d, 2546430 FS+4d | 199d | 51d | 8/5 M-F w/JLAB Holidays ReBaseline | ELEC ENG [40 h]; ELEC TECH [80 h] | 6,764.4 | CHUDAKOV | 1 | 1 | D |  |  | EUGENE C | 11-006 | 11-026 |  | 12-021 | 12-040 |  |  |  |  |  | 282446025 | U | PE | 13-015 | PR | 14-001 | 12-054 |  |

| ID | WBS | Activity | Duration | Start | Finish | Predecessors | Total float | Free float | Calendar | Resources | Cost | Original Activity ID Rebaseline | RESP - Responsibility | STRT%COMP for CM EVM | FNSH%COMP for CM EVM | HALL D Related Milestones | EVMS Reporting Codes | CAM RESPONSIBLE | CR 11-026 | CR 12-021 | CR 12-055 | CR 13-007 | BOE Labor | CR 13-015 | Post Rebaseline | Temple/Lehman | CR 14-001 | CR 11-004 | CR 11-006 | CR 12-054 | CR 07-024 | CR 09-014 | CR 10-042 | 12 GeV 1st level Critical Path | CR 09-027 | CR 09-027 Repair | CR 13-014 | ReBaseline Actuals Adjustment | CR 10-037 | CR 10-050 | CR 11-007 | CR 12-038 | BOE Expenses | CR 11-018 |
| --- | --- | --- | --- | --- | --- | --- | --- | --- | --- | --- | --- | --- | --- | --- | --- | --- | --- | --- | --- | --- | --- | --- | --- | --- | --- | --- | --- | --- | --- | --- | --- | --- | --- | --- | --- | --- | --- | --- | --- | --- | --- | --- | --- | --- |
|  | 5 | **1.8.2.4.5 HALL D BEAMLINE** |  | 2013-09-03 | 2014-09-04 |  |  |  |  |  |  |  |  |  |  |  |  |  |  |  |  |  |  |  |  |  |  |  |  |  |  |  |  |  |  |  |  |  |  |  |  |  |  |  |
|  | 3 | **1.8.2.4.5.3 HALL D BEAMLINE COMPONENT TESTING** |  | 2013-09-03 | 2014-09-04 |  |  |  |  |  |  |  |  |  |  |  |  |  |  |  |  |  |  |  |  |  |  |  |  |  |  |  |  |  |  |  |  |  |  |  |  |  |  |  |
| 282453010 |  | Test PS High Granularity Counters FY13 | 20d | 2013-09-03 | 2013-09-30 | 2553042 FS-20d | 213d | 0d | 8/5 M-F w/JLAB Holidays ReBaseline | ELEC ENG [18.18 h]; ELEC TECH [18.18 h]; SCIENTIST [54.55 h] | 6,126.06 | 2553043 | CHUDAKOV | 1 | 1 | D | U | EUGENE C | 11-026 | 12-021 | 12-055 | 13-007F | PE | 13-015 | PR | LR13 |  |  |  |  |  |  |  |  |  |  |  |  |  |  |  |  |  |  |
| 282453010a |  | Test PS High Granularity Counters FY14 | 24d | 2013-10-01 | 2013-11-01 | 2553042 FS-20d, 282453010 | 213d | 65d | 8/5 M-F w/JLAB Holidays ReBaseline | ELEC ENG [21.82 h]; ELEC TECH [21.82 h]; SCIENTIST [65.45 h] | 7,585.25 | 2553043 | CHUDAKOV | 1 | 1 | D | U | EUGENE C | 11-026 | 12-021 | 12-055 | 13-007F | PE | 13-015 | PR | LR13 | 14-001 |  |  |  |  |  |  |  |  |  |  |  |  |  |  |  |  |  |
| 282453000 |  | Check Operation of Goniometer (BL Compnts) | 160d | 2014-01-21 | 2014-09-04 | 2553165 FS-42d, 2553145 FS-80d, 2553147 FS-80d, 2553170 FS-120d | 18d | 0d | 8/5 M-F w/JLAB Holidays ReBaseline | SCIENTIST [320 h] | 24,057.6 | 2553025 | CHUDAKOV | 1 | 1 | D | S | EUGENE C | 11-026 | 12-021 |  | 13-007 | EJ | 13-015 | PR | LR13 | 14-001 | 11-004 | 11-006 | 12-054 |  |  |  |  |  |  |  |  |  |  |  |  |  |  |
|  | 6 | **1.8.2.4.6 HALL D INFRASTUCTURE** |  | 2013-12-02 | 2014-09-30 |  |  |  |  |  |  |  |  |  |  |  |  |  |  |  |  |  |  |  |  |  |  |  |  |  |  |  |  |  |  |  |  |  |  |  |  |  |  |  |
|  | 2 | **1.8.2.4.6.2 HALL D INSTALLATION TESTING** |  | 2013-12-02 | 2014-09-30 |  |  |  |  |  |  |  |  |  |  |  |  |  |  |  |  |  |  |  |  |  |  |  |  |  |  |  |  |  |  |  |  |  |  |  |  |  |  |  |
| 282462005 |  | Operation Checks FDC (outside Solenoid) (Installtn) | 22d | 2013-12-02 | 2014-01-10 | 2562370c FS-56d, 25211191, 2562370 FS-2d | 0d |  | 8/5 M-F w/JLAB Holidays ReBaseline | MECH ENG [16 h]; ELEC ENG [40 h]; MECH TECH [80 h]; ELEC TECH [160 h]; SCIENTIST [240 h] | 33,547.12 | 2562375 | CHUDAKOV | 1 | 1 | D | S | EUGENE C | 11-026 | 12-021 |  | 13-007 | PE | 13-015 | PR | LR13 | 14-001 |  | 11-006 | 12-054 | 07-024 | 09-014 | 10-042 |  |  |  |  |  |  |  |  |  |  |  |
| 282462050 |  | System Check-out Install Hall FCAL | 20d | 2013-12-02 | 2014-01-08 | 2562700, 2562475ca, 2562475c | 185d |  | 8/5 M-F w/JLAB Holidays ReBaseline | ELEC TECH [240 h]; ELEC ENG [120 h] | 20,293.2 | 2562590 | CHUDAKOV | 1 | 1 | D | S | EUGENE C | 11-026 | 12-021 |  | 13-007 | PE | 13-015 | PR | LR13 | 14-001 |  | 11-006 | 12-054 |  |  |  | 1 |  |  |  |  |  |  |  |  |  |  |
| 282462040 |  | System Check-out Install Hall BCAL | 90d | 2014-01-31 | 2014-06-06 | 2562275c, 2562540, 2546660 | 80d |  | 8/5 M-F w/JLAB Holidays ReBaseline | ELEC TECH [240 h]; ELEC ENG [120 h] | 20,293.2 | 2562580 | CHUDAKOV | 1 | 1 | D | S | EUGENE C | 11-026 | 12-021 |  | 13-007 | PE | 13-015 | PR | LR13 | 14-001 |  | 11-006 | 12-054 |  |  |  | 1 |  |  |  |  |  |  |  |  |  |  |
| 282462010 |  | Operation Checks FDC (Inside Solenoid) (Installtn) | 168d | 2014-02-04 | 2014-09-30 | 2562393, 2562385 | 0d |  | 8/5 M-F w/JLAB Holidays ReBaseline | ELEC ENG [80 h]; MECH ENG [40 h]; MECH TECH [120 h]; ELEC TECH [80 h]; SCIENTIST [560 h] | 60,535.6 | 2562390 | CHUDAKOV | 1 | 1 | D | S | EUGENE C | 11-026 | 12-021 |  | 13-007 | PE | 13-015 | PR | LR13 | 14-001 |  | 11-006 | 12-054 | 07-024 | 09-014 | 10-042 |  |  |  |  |  |  |  |  |  |  |  |
| 282462030 |  | System Check-out Install Hall CDC | 38d | 2014-02-12 | 2014-04-04 | 2562530, 2562750, 2562290c | 124d |  | 8/5 M-F w/JLAB Holidays ReBaseline | ELEC TECH [160 h]; ELEC ENG [80 h] | 13,528.8 | 2562570 | CHUDAKOV | 1 | 1 | D | S | EUGENE C | 11-026 | 12-021 |  | 13-007 | PE | 13-015 | PR | LR13 | 14-001 |  | 11-006 | 12-054 |  |  |  | 1 |  |  |  |  |  |  |  |  |  |  |
| 282462020 |  | System Check-out Install Hall Pair Spectrometer | 10d | 2014-02-18 | 2014-03-03 | 2562520, 282446025, 2562246, 2562099c FS+3d, 282453010a, 282453010 | 148d |  | 8/5 M-F w/JLAB Holidays ReBaseline | ELEC TECH [80 h]; ELEC ENG [40 h] | 6,764.4 | 2562560 | CHUDAKOV | 1 | 1 | D | S | EUGENE C | 11-026 | 12-021 |  | 13-007 | PE | 13-015 | PR | LR13 | 14-001 |  | 11-006 | 12-054 |  |  |  | 1 |  |  |  |  |  |  |  |  |  |  |
| 282462035 |  | System Check-out Install Hall FDC | 60d | 2014-02-26 | 2014-05-20 | 2562715, 2562370c, 2562535 | 92d |  | 8/5 M-F w/JLAB Holidays ReBaseline | ELEC TECH [240 h]; ELEC ENG [120 h] | 20,293.2 | 2562575 | CHUDAKOV | 1 | 1 | D | S | EUGENE C | 11-026 | 12-021 |  | 13-007 | PE | 13-015 | PR | LR13 | 14-001 |  | 11-006 | 12-054 |  |  |  | 1 |  |  |  |  |  |  |  |  |  |  |
| 282462000 |  | Operational Checks CDC (Inside Solenoid) (Installtn) | 94d | 2014-03-28 | 2014-08-08 | 2562280 FS-19d, 2562303 FS-10d, 2562300, 2562301 FS+1d | 17d | 6d | 8/5 M-F w/JLAB Holidays ReBaseline | ELEC TECH [80 h]; MECH ENG [40 h]; MECH TECH [40 h]; SCIENTIST [320 h] | 32,696.4 | 2562305 | CHUDAKOV | 1 | 1 | D | S | EUGENE C | 11-026 | 12-021 |  | 13-007 | PE | 13-015 | PR | LR13 | 14-001 |  | 11-006 | 12-054 | 07-024 | 09-014 | 10-042 | 1 | 09-027 | 09-027 |  |  |  |  |  |  |  |  |
| 282462045 |  | System Check-out Install Hall TOF | 20d | 2014-06-03 | 2014-06-30 | 2562455c, 2562545 | 64d |  | 8/5 M-F w/JLAB Holidays ReBaseline | ELEC TECH [80 h]; ELEC ENG [40 h] | 6,764.4 | 2562585 | CHUDAKOV | 1 | 1 | D | S | EUGENE C | 11-026 | 12-021 |  | 13-007 | PE | 13-015 | PR | LR13 | 14-001 |  | 11-006 | 12-054 |  |  |  | 1 |  |  |  |  |  |  |  |  |  |  |
| 282462015 |  | System Check-out Install Hall Tagger | 10d | 2014-06-12 | 2014-06-25 | 2562515, 2562095c | 67d |  | 8/5 M-F w/JLAB Holidays ReBaseline | ELEC TECH [80 h]; ELEC ENG [40 h] | 6,764.4 | 2562555 | CHUDAKOV | 1 | 1 | D | S | EUGENE C | 11-026 | 12-021 |  | 13-007 | PE | 13-015 | PR | LR13 | 14-001 |  | 11-006 | 12-054 |  |  |  | 1 |  |  |  |  |  |  |  |  |  |  |
| 282462025 |  | System Check-out Install Hall Start Counter | 7d | 2014-07-24 | 2014-08-01 | 2562525, 2562490c FS-25d | 41d |  | 8/5 M-F w/JLAB Holidays ReBaseline | ELEC TECH [80 h]; ELEC ENG [40 h] | 6,764.4 | 2562565 | CHUDAKOV | 1 | 1 | D | S | EUGENE C | 11-026 | 12-021 |  | 13-007 | PE | 13-015 | PR | LR13 | 14-001 |  | 11-006 | 12-054 |  |  |  | 1 |  |  |  |  |  |  |  |  |  |  |
|  | 3 | **1.8.3 PRE-OPS SUPPORT** |  | 2013-08-30 | 2016-06-30 |  |  |  |  |  |  |  |  |  |  |  |  |  |  |  |  |  |  |  |  |  |  |  |  |  |  |  |  |  |  |  |  |  |  |  |  |  |  |  |
|  | 1 | **1.8.3.1 PRE-OPS SUPPORT - PROJECT OFFICE** |  | 2013-08-30 | 2016-06-30 |  |  |  |  |  |  |  |  |  |  |  |  |  |  |  |  |  |  |  |  |  |  |  |  |  |  |  |  |  |  |  |  |  |  |  |  |  |  |  |
| 1831950 |  | Re-Baseline Actuals Adjustment | 1d | 2013-08-30 | 2013-08-30 | 9-130M FS+227d | 20d |  |  | PROCUREMENT>$50K 69 NO ESCALATION | 256,353.84 |  | RODE C | 1 | 1 |  |  | CLAUS R |  |  |  |  |  |  |  |  |  |  |  |  |  |  |  |  |  |  | 13-014 | ADJ |  |  |  |  |  |  |
| 2831913LOE |  | FY13 Pre-Ops Supprt - Proj Office | 20d | 2013-09-03 | 2013-09-30 | 9-130M FS+228d | 311d | 0d | 8/5 M-F w/JLAB Holidays ReBaseline | SCIENTIST [14.07 h]; OFFICE [140.8 h]; SUPPLIES & MATERIALS; SR STAFF [179.51 h]; DIRECTORATE [123.18 h]; ADMIN [70.4 h]; ELEC ENG [35.2 h]; MECH ENG [140.8 h] | 69,025.92 | 2831913LOE | RODE C | 1 | 1 |  |  | CLAUS R |  |  |  |  | PE | 13-015 | PR |  |  |  |  |  |  |  |  |  |  |  |  |  | 10-037 | 10-050 | 11-007 | 12-038 | PE |  |
| 2831914LOE |  | FY14 Pre-Ops Supprt - Proj Office | 247d | 2013-10-01 | 2014-09-30 | 2831913LOE | 311d | 0d | 8/5 M-F w/JLAB Holidays ReBaseline | SCIENTIST [176 h]; OFFICE [1760 h]; SUPPLIES & MATERIALS; SR STAFF [2244 h]; DIRECTORATE [1737.4 h]; ADMIN [880 h]; ELEC ENG [440 h]; MECH ENG [1760 h] | 930,872.11 | 2831914LOE | RODE C | 1 | 1 |  |  | CLAUS R |  |  |  |  | PE | 13-015 | PR |  | 14-001 |  |  |  |  |  |  |  |  |  |  |  | 10-037 | 10-050 | 11-007 | 12-038 | PE |  |
| 2831915LOE |  | FY15 Pre-Ops Supprt - Proj Office | 247d | 2014-10-01 | 2015-10-01 | 271914LOE, 2831914LOE | 311d | 0d | 8/5 M-F w/JLAB Holidays ReBaseline | MECH ENG [3520 h]; SR STAFF [4488 h]; SCIENTIST [352 h]; DIRECTORATE [3080 h]; OFFICE [3520 h]; ELEC ENG [880 h]; SUPPLIES & MATERIALS; ADMIN [1760 h] | 1,780,146.32 | 2831915LOE | RODE C | 1 | 1 |  |  | ROLF E |  |  |  |  | PE | 13-015 | PR |  | 14-001 |  |  |  |  |  |  |  |  |  |  |  |  | 10-050 |  |  | PE |  |
| 2831916LOE |  | FY16 Pre-Ops Supprt - Proj Office | 184d | 2015-10-02 | 2016-06-30 | 2831915LOE | 311d |  | 8/5 M-F w/JLAB Holidays ReBaseline | SR STAFF [3366 h]; OFFICE [2640 h]; ELEC ENG [660 h]; DIRECTORATE [2310 h]; SUPPLIES & MATERIALS; ADMIN [1320 h]; SCIENTIST [264 h]; MECH ENG [2640 h] | 1,345,428.74 | 2831916LOE | RODE C | 1 | 1 |  |  | ROLF E |  |  |  |  | PE | 13-015 | PR |  | 14-001 |  |  |  |  |  |  |  |  |  |  |  |  | 10-050 |  |  | PE | 11-018 |

| ID | WBS | Activity | Duration | Start | Finish | Predecessors | Total float | Free float | Calendar | Resources | Cost | RESP - Responsibility | STRT%COMP for CM EVM | FNSH%COMP for CM EVM | CAM RESPONSIBLE | CR 13-014 | ReBaseline Actuals Adjustment | HALL D Related Milestones | CR 10-046 | CR 11-006 | CR 11-026 | CR 12-054 | Original Activity ID Rebaseline | EVMS Reporting Codes | CR 13-007 | BOE Procurement | CR 13-015 | Post Rebaseline | Obligated Prior to Rebaseline |
| --- | --- | --- | --- | --- | --- | --- | --- | --- | --- | --- | --- | --- | --- | --- | --- | --- | --- | --- | --- | --- | --- | --- | --- | --- | --- | --- | --- | --- | --- |
|  | 2 | **1.8.3.2 PRE-OPS SUPPORT - OFFICE OF PROJECT MANAGEMENT** |  |  |  |  |  |  |  |  |  |  |  |  |  |  |  |  |  |  |  |  |  |  |  |  |  |  |  |
|  | 9 | **1.9 VA STATE** |  | 2010-03-01 | 2013-10-31 |  |  |  |  |  |  |  |  |  |  |  |  |  |  |  |  |  |  |  |  |  |  |  |  |
|  | 5 | **1.9.5 HALL D - VA STATE** |  | 2010-03-01 | 2013-10-31 |  |  |  |  |  |  |  |  |  |  |  |  |  |  |  |  |  |  |  |  |  |  |  |  |
|  | 1 | **1.9.5.1 NOT USED** |  | 2013-08-30 | 2013-08-30 |  |  |  |  |  |  |  |  |  |  |  |  |  |  |  |  |  |  |  |  |  |  |  |  |
| 1951000 |  | Re-Baseline Actuals Adjustment | 1d | 2013-08-30 | 2013-08-30 | 9-130M FS+227d | 20d |  |  | PROCUREMENT>$50K 69 NO ESCALATION | 193,321.29 | CHUDAKOV | 1 | 1 | EUGENE C | 13-014 | ADJ |  |  |  |  |  |  |  |  |  |  |  |  |
|  | 2 | **1.9.5.2 HALL D DETECTORS** |  | 2010-03-01 | 2013-10-31 |  |  |  |  |  |  |  |  |  |  |  |  |  |  |  |  |  |  |  |  |  |  |  |  |
|  | 1 | **1.9.5.2.1 HALL D TRACKING** |  | 2010-04-06 | 2013-10-31 |  |  |  |  |  |  |  |  |  |  |  |  |  |  |  |  |  |  |  |  |  |  |  |  |
|  | 2 | **1.9.5.2.1.2 HALL D CENTRAL CHAMBERS** |  | 2010-04-06 | 2013-10-31 |  |  |  |  |  |  |  |  |  |  |  |  |  |  |  |  |  |  |  |  |  |  |  |  |
| 195212010 |  | Procurement epoxy with delivery in phases (P1 Construction Setup & Straw Penetration) | 82d | 2010-04-06 | 2010-07-30 | 9-100M FS+123d | 58d | 0d |  | PROCUREMENT<$50K 60 NO ESCALATION | 22,373 | CHUDAKOV | 1 | 1 | EUGENE C |  |  | D | 10-046 | 11-006 | 11-026 | 12-054F |  |  |  |  |  |  |  |
| 195212015 |  | Installation mandril and end plates (P1 Construction Setup & Straw Penetration) | 82d | 2010-04-06 | 2010-07-30 | 195212010 FS-82d | 58d | 0d |  | PROCUREMENT<$50K 60 NO ESCALATION | 6,391 | CHUDAKOV | 1 | 1 | EUGENE C |  |  | D | 10-046 | 11-006 | 11-026 | 12-054F |  |  |  |  |  |  |  |
| 195212020 |  | Aligned and fix end plates (P1 Construction Setup & Straw Penetration) (P2 Straw Insertion) | 82d | 2010-04-06 | 2010-07-30 | 195212015 FS-82d | 58d | 0d |  | PROCUREMENT<$50K 60 NO ESCALATION | 19,172 | CHUDAKOV | 1 | 1 | EUGENE C |  |  | D | 10-046 | 11-006 | 11-026 | 12-054F |  |  |  |  |  |  |  |
| 195212025 |  | Straw Preparation Axial section I (P2 Straw Insertion) | 104d | 2010-04-06 | 2010-08-31 | 195212020 FS-82d | 58d | 0d |  | PROCUREMENT>$50K 69 NO ESCALATION; PROCUREMENT<$50K 60 NO ESCALATION | 3,167.5 | CHUDAKOV | 1 | 1 | EUGENE C |  |  | D | 10-046 | 11-006 | 11-026 | 12-054F |  |  |  |  |  |  |  |
| 195212030 |  | Insert straws Axial section I (P2 Straw Insertion) | 104d | 2010-04-06 | 2010-08-31 | 195212025 FS-104d | 58d | 0d |  | PROCUREMENT>$50K 69 NO ESCALATION | 3,167.5 | CHUDAKOV | 1 | 1 | EUGENE C |  |  | D | 10-046 | 11-006 | 11-026 | 12-054F |  |  |  |  |  |  |  |
| 195212035 |  | Straw preparation Stereo section I-L (P2 Straw Insertion) | 104d | 2010-04-06 | 2010-08-31 | 195212030 FS-104d | 58d | 0d |  | PROCUREMENT>$50K 69 NO ESCALATION | 4,701.5 | CHUDAKOV | 1 | 1 | EUGENE C |  |  | D | 10-046 | 11-006 | 11-026 | 12-054F |  |  |  |  |  |  |  |
| 195212040 |  | Insert straws Stereo section 1-L (Phase 2 Straw Insertion) | 104d | 2010-04-06 | 2010-08-31 | 195212035 FS-104d | 58d | 0d |  | PROCUREMENT>$50K 69 NO ESCALATION | 4,701.5 | CHUDAKOV | 1 | 1 | EUGENE C |  |  | D | 10-046 | 11-006 | 11-026 | 12-054F |  |  |  |  |  |  |  |
| 195212045 |  | Straw preparation Stereo section 1-R (P2 Straw Insertion) | 125d | 2010-04-06 | 2010-09-30 | 195212040 FS-104d | 58d | 0d |  | PROCUREMENT>$50K 69 NO ESCALATION | 6,363 | CHUDAKOV | 1 | 1 | EUGENE C |  |  | D | 10-046 | 11-006 | 11-026 | 12-054F |  |  |  |  |  |  |  |
| 195212050 |  | Insert straws Stereo section 1-R (P2 Straw Insertion) | 125d | 2010-04-06 | 2010-09-30 | 195212045 FS-125d | 58d | 0d |  | PROCUREMENT>$50K 69 NO ESCALATION | 6,363 | CHUDAKOV | 1 | 1 | EUGENE C |  |  | D | 10-046 | 11-006 | 11-026 | 12-054F |  |  |  |  |  |  |  |
| 195212055 |  | Straw preparation Axial section 2 (P2 Straw Insertion) | 125d | 2010-04-06 | 2010-09-30 | 195212050 FS-125d | 58d | 0d |  | PROCUREMENT>$50K 69 NO ESCALATION | 8,280 | CHUDAKOV | 1 | 1 | EUGENE C |  |  | D | 10-046 | 11-006 | 11-026 | 12-054F |  |  |  |  |  |  |  |
| 195212060 |  | Insert straws axial section 2 (P2 Straw Insertion) | 146d | 2010-04-06 | 2010-10-29 | 195212055 FS-125d | 58d | 0d |  | PROCUREMENT>$50K 69 NO ESCALATION | 8,280 | CHUDAKOV | 1 | 1 | EUGENE C |  |  | D | 10-046 | 11-006 | 11-026 | 12-054F |  |  |  |  |  |  |  |
| 195212065 |  | Straw preparation stereo section 2-R-1 (P2 Straw Insertion) | 166d | 2010-04-06 | 2010-11-30 | 195212060 FS-146d | 58d | 0d |  | PROCUREMENT>$50K 69 NO ESCALATION | 4,733.5 | CHUDAKOV | 1 | 1 | EUGENE C |  |  | D | 10-046 | 11-006 | 11-026 | 12-054F |  |  |  |  |  |  |  |
| 195212070 |  | Insert strwas stereo section 2-R-1 (P2 Straw Insertion) | 166d | 2010-04-06 | 2010-11-30 | 195212065 FS-166d | 58d | 0d |  | PROCUREMENT>$50K 69 NO ESCALATION | 4,733.5 | CHUDAKOV | 1 | 1 | EUGENE C |  |  | D | 10-046 | 11-006 | 11-026 | 12-054F |  |  |  |  |  |  |  |
| 195212075 |  | Straw preparation stereo section 2-R-2 (P2 Straw Insertion) | 183d | 2010-04-06 | 2010-12-30 | 195212070 FS-166d | 58d | 0d |  | PROCUREMENT>$50K 69 NO ESCALATION | 5,117 | CHUDAKOV | 1 | 1 | EUGENE C |  |  | D | 10-046 | 11-006 | 11-026 | 12-054F |  |  |  |  |  |  |  |
| 195212080 |  | Insert straws stereo section 2-R-2 (P2 Straw Insertion) | 183d | 2010-04-06 | 2010-12-30 | 195212075 FS-183d | 58d | 0d |  | PROCUREMENT>$50K 69 NO ESCALATION | 5,117 | CHUDAKOV | 1 | 1 | EUGENE C |  |  | D | 10-046 | 11-006 | 11-026 | 12-054F |  |  |  |  |  |  |  |
| 195212085 |  | Straw preparation stereo section 2-L-1 (P2 Straw Insertion) | 203d | 2010-04-06 | 2011-01-31 | 195212080 FS-183d | 58d | 0d |  | PROCUREMENT>$50K 69 NO ESCALATION | 5,500 | CHUDAKOV | 1 | 1 | EUGENE C |  |  | D | 10-046 | 11-006 | 11-026 | 12-054F |  |  |  |  |  |  |  |
| 195212090 |  | Insert straws stereo section 2-L-1 (P2 Straw Insertion) | 203d | 2010-04-06 | 2011-01-31 | 195212085 FS-203d | 58d | 0d |  | PROCUREMENT>$50K 69 NO ESCALATION | 5,500 | CHUDAKOV | 1 | 1 | EUGENE C |  |  | D | 10-046 | 11-006 | 11-026 | 12-054F |  |  |  |  |  |  |  |
| 195212095 |  | Straw preparation stereo section 2-L-2 (P2 Straw Insertion) | 203d | 2010-04-06 | 2011-01-31 | 195212090 FS-203d | 58d | 0d |  | PROCUREMENT>$50K 69 NO ESCALATION | 5,883.5 | CHUDAKOV | 1 | 1 | EUGENE C |  |  | D | 10-046 | 11-006 | 11-026 | 12-054F |  |  |  |  |  |  |  |
| 195212100 |  | Insert straws stereo section 2-L-2 (P2 Straw Insertion) | 203d | 2010-04-06 | 2011-01-31 | 195212095 FS-203d | 58d | 0d |  | PROCUREMENT>$50K 69 NO ESCALATION | 5,883.5 | CHUDAKOV | 1 | 1 | EUGENE C |  |  | D | 10-046 | 11-006 | 11-026 | 12-054F |  |  |  |  |  |  |  |
| 195212105 |  | Straw preparation Axial Section 3-1 (P2 Straw Insertion) | 222d | 2010-04-06 | 2011-02-28 | 195212100 FS-203d | 58d | 0d |  | PROCUREMENT>$50K 69 NO ESCALATION | 6,395 | CHUDAKOV | 1 | 1 | EUGENE C |  |  | D | 10-046 | 11-006 | 11-026 | 12-054F |  |  |  |  |  |  |  |
| 195212110 |  | Insert straws axial section 3-1 (P2 Straw Insertion) | 222d | 2010-04-06 | 2011-02-28 | 195212105 FS-222d | 58d | 0d |  | PROCUREMENT>$50K 69 NO ESCALATION | 6,395 | CHUDAKOV | 1 | 1 | EUGENE C |  |  | D | 10-046 | 11-006 | 11-026 | 12-054F |  |  |  |  |  |  |  |
| 195212115 |  | Straw preparation Axial Section 3-2 (P2 Straw Insertion) | 245d | 2010-04-06 | 2011-03-31 | 195212110 FS-222d | 58d | 0d |  | PROCUREMENT>$50K 69 NO ESCALATION | 6,778.5 | CHUDAKOV | 1 | 1 | EUGENE C |  |  | D | 10-046 | 11-006 | 11-026 | 12-054F |  |  |  |  |  |  |  |
| 195212120 |  | Insert Straws Axial Section 3-2 (P2 Straw Insertion) | 245d | 2010-04-06 | 2011-03-31 | 195212115 FS-245d | 58d | 0d |  | PROCUREMENT>$50K 69 NO ESCALATION | 6,778.5 | CHUDAKOV | 1 | 1 | EUGENE C |  |  | D | 10-046 | 11-006 | 11-026 | 12-054F |  |  |  |  |  |  |  |
| 195212125 |  | Install Gas lines in CDC volume (P3 Shell Installation) | 266d | 2010-04-06 | 2011-04-29 | 195212120 FS-245d | 58d | 0d |  | PROCUREMENT>$50K 69 NO ESCALATION | 2,768.7 | CHUDAKOV | 1 | 1 | EUGENE C |  |  | D | 10-046 | 11-006 | 11-026 | 12-054F |  |  |  |  |  |  |  |
| 195212130 |  | Install sensors in CDC Volume (P3 Shell Installation) | 266d | 2010-04-06 | 2011-04-29 | 195212125 FS-266d | 58d | 0d |  | PROCUREMENT>$50K 69 NO ESCALATION | 1,426.3 | CHUDAKOV | 1 | 1 | EUGENE C |  |  | D | 10-046 | 11-006 | 11-026 | 12-054F |  |  |  |  |  |  |  |
| 195212135 |  | Installation outer shell (P3 Shell Installation) | 287d | 2010-04-06 | 2011-05-31 | 195212130 FS-266d | 58d | 0d |  | PROCUREMENT>$50K 69 NO ESCALATION | 10,586 | CHUDAKOV | 1 | 1 | EUGENE C |  |  | D | 10-046 | 11-006 | 11-026 | 12-054F |  |  |  |  |  |  |  |
| 195212140 |  | String 1st axial section (P3 Chamber stringing) | 287d | 2010-04-06 | 2011-05-31 | 195212135 FS-287d | 58d | 0d |  | PROCUREMENT>$50K 69 NO ESCALATION | 6,335 | CHUDAKOV | 1 | 1 | EUGENE C |  |  | D | 10-046 | 11-006 | 11-026 | 12-054F |  |  |  |  |  |  |  |
| 195212145 |  | String 1st stereo section (P3 Chamber stringing) | 309d | 2010-04-06 | 2011-06-30 | 195212140 FS-287d | 58d | 0d |  | PROCUREMENT>$50K 69 NO ESCALATION | 9,403 | CHUDAKOV | 1 | 1 | EUGENE C |  |  | D | 10-046 | 11-006 | 11-026 | 12-054F |  |  |  |  |  |  |  |
| 195212150 |  | String 2nd stereo section (P3 Chamber stringing) | 287d | 2010-04-06 | 2011-05-31 | 195212145 FS-309d | 58d | 0d |  | PROCUREMENT>$50K 69 NO ESCALATION | 12,726 | CHUDAKOV | 1 | 1 | EUGENE C |  |  | D | 10-046 | 11-006 | 11-026 | 12-054F |  |  |  |  |  |  |  |
| 195212155 |  | String 2nd axial section (P3 Chamber stringing) | 352d | 2010-04-06 | 2011-08-31 | 195212150 FS-287d | 58d | 0d |  | PROCUREMENT>$50K 69 NO ESCALATION | 16,560 | CHUDAKOV | 1 | 1 | EUGENE C |  |  | D | 10-046 | 11-006 | 11-026 | 12-054F |  |  |  |  |  |  |  |
| 195212160 |  | String 3rd stereo section (inner) (P3 Chamber stringing) | 352d | 2010-04-06 | 2011-08-31 | 195212155 FS-352d | 58d | 0d |  | PROCUREMENT>$50K 69 NO ESCALATION | 9,467 | CHUDAKOV | 1 | 1 | EUGENE C |  |  | D | 10-046 | 11-006 | 11-026 | 12-054F |  |  |  |  |  |  |  |
| 195212165 |  | String 3rd stereo section (outer) (P3 Chamber stringing) | 373d | 2010-04-06 | 2011-09-30 | 195212160 FS-352d | 58d | 0d |  | PROCUREMENT>$50K 69 NO ESCALATION | 10,234 | CHUDAKOV | 1 | 1 | EUGENE C |  |  | D | 10-046 | 11-006 | 11-026 | 12-054F |  |  |  |  |  |  |  |
| 195212170 |  | String 4th stereo section (inner) (P3 Chamber stringing) | 394d | 2010-04-06 | 2011-10-31 | 195212165 FS-373d | 58d | 0d |  | PROCUREMENT>$50K 69 NO ESCALATION | 11,000 | CHUDAKOV | 1 | 1 | EUGENE C |  |  | D | 10-046 | 11-006 | 11-026 | 12-054F |  |  |  |  |  |  |  |
| 195212175 |  | String 4th stereo section (outer) (P3 Chamber stringing) | 414d | 2010-04-06 | 2011-11-30 | 195212170 FS-394d | 58d | 0d |  | PROCUREMENT>$50K 69 NO ESCALATION | 11,767 | CHUDAKOV | 1 | 1 | EUGENE C |  |  | D | 10-046 | 11-006 | 11-026 | 12-054F |  |  |  |  |  |  |  |
| 195212180 |  | String 3rd axial section (inner) (P3 Chamber stringing) | 431d | 2010-04-06 | 2011-12-30 | 195212175 FS-414d | 58d | 0d |  | PROCUREMENT>$50K 69 NO ESCALATION | 12,790 | CHUDAKOV | 1 | 1 | EUGENE C |  |  | D | 10-046 | 11-006 | 11-026 | 12-054F |  |  |  |  |  |  |  |
| 195212185 |  | String 3rd axial section (outer) (P3 Chamber stringing) | 451d | 2010-04-06 | 2012-01-31 | 195212180 FS-431d | 58d | 0d |  | PROCUREMENT>$50K 69 NO ESCALATION | 13,557 | CHUDAKOV | 1 | 1 | EUGENE C |  |  | D | 10-046 | 11-006 | 11-026 | 12-054F |  |  |  |  |  |  |  |
| 195212190 |  | Electronics installation 1st axial section (P4 Chamber instrumentation) | 451d | 2010-04-06 | 2012-01-31 | 195212185 FS-451d | 58d | 0d |  | PROCUREMENT>$50K 69 NO ESCALATION | 4,162 | CHUDAKOV | 1 | 1 | EUGENE C |  |  | D | 10-046 | 11-006 | 11-026 | 12-054F |  |  |  |  |  |  |  |
| 195212195 |  | Electronics installation 1st stereo section (P4 Chamber instrumentation) | 471d | 2010-04-06 | 2012-02-29 | 195212190 FS-451d | 58d | 0d |  | PROCUREMENT>$50K 69 NO ESCALATION | 6,143 | CHUDAKOV | 1 | 1 | EUGENE C |  |  | D | 10-046 | 11-006 | 11-026 | 12-054F |  |  |  |  |  |  |  |
| 195212200 |  | Electronics installation 2nd stereo section (P4 Chamber instrumentation) | 471d | 2010-04-06 | 2012-02-29 | 195212195 FS-471d | 58d | 0d |  | PROCUREMENT>$50K 69 NO ESCALATION | 8,290 | CHUDAKOV | 1 | 1 | EUGENE C |  |  | D | 10-046 | 11-006 | 11-026 | 12-054F |  |  |  |  |  |  |  |
| 195212205 |  | Electronics installation 2nd axial section (P4 Chamber instrumentation) | 493d | 2010-04-06 | 2012-03-30 | 195212200 FS-471d | 58d | 0d |  | PROCUREMENT>$50K 69 NO ESCALATION | 10,766 | CHUDAKOV | 1 | 1 | EUGENE C |  |  | D | 10-046 | 11-006 | 11-026 | 12-054F |  |  |  |  |  |  |  |
| 195212210 |  | Electronics installation 3rd stereo section (inner) (P4 Chamber instrumentation) | 493d | 2010-04-06 | 2012-03-30 | 195212205 FS-493d | 58d | 0d |  | PROCUREMENT>$50K 69 NO ESCALATION | 6,185 | CHUDAKOV | 1 | 1 | EUGENE C |  |  | D | 10-046 | 11-006 | 11-026 | 12-054F |  |  |  |  |  |  |  |
| 195212215 |  | Electronics installation 3rd stereo section (outer) (P4 Chamber instrumentation) | 514d | 2010-04-06 | 2012-04-30 | 195212210 FS-493d | 58d | 0d |  | PROCUREMENT>$50K 69 NO ESCALATION | 6,680 | CHUDAKOV | 1 | 1 | EUGENE C |  |  | D | 10-046 | 11-006 | 11-026 | 12-054F |  |  |  |  |  |  |  |
| 195212220 |  | Electronics installation 4th stereo section (inner) (P4 Chamber instrumentation) | 514d | 2010-04-06 | 2012-04-30 | 195212215 FS-514d | 58d | 0d |  | PROCUREMENT>$50K 69 NO ESCALATION | 7,175 | CHUDAKOV | 1 | 1 | EUGENE C |  |  | D | 10-046 | 11-006 | 11-026 | 12-054F |  |  |  |  |  |  |  |
| 195212225 |  | Electronics installation 4th stereo section (outer) (P4 Chamber instrumentation) | 536d | 2010-04-06 | 2012-05-31 | 195212220 FS-514d | 58d | 0d |  | PROCUREMENT>$50K 69 NO ESCALATION | 7,671 | CHUDAKOV | 1 | 1 | EUGENE C |  |  | D | 10-046 | 11-006 | 11-026 | 12-054F |  |  |  |  |  |  |  |
| 195212230 |  | Electronics installation 3rd axial section (inner) (P4 Chamber instrumentation) | 536d | 2010-04-06 | 2012-05-31 | 195212225 FS-536d | 58d | 0d |  | PROCUREMENT>$50K 69 NO ESCALATION | 8,331 | CHUDAKOV | 1 | 1 | EUGENE C |  |  | D | 10-046 | 11-006 | 11-026 | 12-054F |  |  |  |  |  |  |  |
| 195212235 |  | Electronics installation 3rd axial section (outer) (P4 Chamber instrumentation) | 556d | 2010-04-06 | 2012-06-29 | 195212230 FS-536d | 58d | 0d |  | PROCUREMENT>$50K 69 NO ESCALATION | 8,826 | CHUDAKOV | 1 | 1 | EUGENE C |  |  | D | 10-046 | 11-006 | 11-026 | 12-054F |  |  |  |  |  |  |  |
| 195212240 |  | Close up gas upstream and downstream gas plenum (P5 Chamber operational tests) | 578d | 2010-04-06 | 2012-07-31 | 195212235 FS-556d | 58d | 0d |  | PROCUREMENT>$50K 69 NO ESCALATION | 10,086 | CHUDAKOV | 1 | 1 | EUGENE C |  |  | D | 10-046 | 11-006 | 11-026 | 12-054F |  |  |  |  |  |  |  |
| 195212245 |  | Gas leak tests (P5 Chamber operational tests) | 601d | 2010-04-06 | 2012-08-31 | 195212240 FS-578d | 58d | 0d |  | PROCUREMENT>$50K 69 NO ESCALATION | 16,477 | CHUDAKOV | 1 | 1 | EUGENE C |  |  | D | 10-046 | 11-006 | 11-026 | 12-054F |  |  |  |  |  |  |  |
| 195212250 |  | HV tests (P5 Chamber operational tests) | 643d | 2010-04-06 | 2012-10-31 | 195212245 FS-601d | 58d | 0d |  | PROCUREMENT>$50K 69 NO ESCALATION | 15,768 | CHUDAKOV | 1 | 1 | EUGENE C |  |  | D | 10-046 | 11-006 | 11-026 | 12-054F |  |  |  |  |  |  |  |
| 195212255 |  | Operations Test (P5 Chamber operational tests) | 719d | 2010-04-06 | 2013-02-28 | 195212250 FS-643d | 58d | 0d |  | PROCUREMENT>$50K 69 NO ESCALATION | 10,446 | CHUDAKOV | 1 | 1 | EUGENE C |  |  | D | 10-046 | 11-006 | 11-026 | 12-054F |  |  |  |  |  |  |  |
| 195212260 |  | Phase 7 Chamber shipping | 740d | 2010-04-06 | 2013-03-29 | 195212255 FS-719d | 58d | 4d |  | PROCUREMENT>$50K 69 NO ESCALATION | 5,000 | CHUDAKOV | 1 | 1 | EUGENE C |  |  | D | 10-046 | 11-006 | 11-026 | 12-054F |  |  |  |  |  |  |  |
| 195212265 |  | Re-Baseline Actuals Adjustment | 1d | 2013-08-30 | 2013-08-30 | 9-130M FS+227d | 20d |  |  | PROCUREMENT>$50K 69 NO ESCALATION | -61,782.34 | CHUDAKOV | 1 | 1 | EUGENE C | 13-014 | ADJ |  |  |  |  |  |  |  |  |  |  |  |  |
| 295212255 |  | Operations Test (P5 Chamber operational tests) | 43d | 2013-09-03 | 2013-10-31 | 9-130M FS+228d | 63d | 0d | 8/5 M-F w/JLAB Holidays ReBaseline | PROCUREMENT<$50K 60 NO ESCALATION; PROCUREMENT>$50K 69 NO ESCALATION | 56,782.34 | CHUDAKOV | 1 | 1 | EUGENE C |  |  | D | 10-046 | 11-006 | 11-026 | 12-054F | 295212255 | D | 13-007F | OB | 13-015 | PR | OB |
| 295212260 |  | Phase 7 Chamber shipping | 43d | 2013-09-03 | 2013-10-31 | 295212255 FS-43d | 63d | 0d | 8/5 M-F w/JLAB Holidays ReBaseline | PROCUREMENT>$50K 69 NO ESCALATION | 5,000 | CHUDAKOV | 1 | 1 | EUGENE C |  |  | D | 10-046 | 11-006 | 11-026 | 12-054F | 295212260 | D | 13-007F | OB | 13-015 | PR | OB |

| ID | WBS | Activity | Duration | Start | Finish | Predecessors | Total float | Free float | Resources | Cost | RESP - Responsibility | STRT%COMP for CM EVM | FNSH%COMP for CM EVM | CAM RESPONSIBLE | CR 13-014 | ReBaseline Actuals Adjustment | HALL D Related Milestones | Advance Purchase Plan > 500K | 12 GEV MAJOR PROCUREMENT CATAGORY | CR 09-043 | CR 10-001 | CR 10-034 | CR 11-006 | CR 11-026 | CR 12-021 | CR 12-054 | CR 09-014 | CR 08-016 | 12 GeV 1st level Critical Path | CR 09-027 | CR 09-027 Repair | CIVIL CRITICAL MILESTONES | CR 07-024 | CR 09-004 | CR 09-052 |
| --- | --- | --- | --- | --- | --- | --- | --- | --- | --- | --- | --- | --- | --- | --- | --- | --- | --- | --- | --- | --- | --- | --- | --- | --- | --- | --- | --- | --- | --- | --- | --- | --- | --- | --- | --- |
|  | 4 | **1.9.5.2.4 HALL D DETECTOR SUPPORT** |  | 2013-08-30 | 2013-08-30 |  |  |  |  |  |  |  |  |  |  |  |  |  |  |  |  |  |  |  |  |  |  |  |  |  |  |  |  |  |  |
| 19524000 |  | Re-Baseline Actuals Adjustment | 1d | 2013-08-30 | 2013-08-30 | 9-130M FS+227d | 20d |  | PROCUREMENT>$50K 69 NO ESCALATION |  | CHUDAKOV | 1 | 1 | EUGENE C | 13-014 | ADJ |  |  |  |  |  |  |  |  |  |  |  |  |  |  |  |  |  |  |  |
|  | 2 | **1.9.5.2.2 HALL D CALORIMETRY** |  | 2010-03-01 | 2013-10-31 |  |  |  |  |  |  |  |  |  |  |  |  |  |  |  |  |  |  |  |  |  |  |  |  |  |  |  |  |  |  |
|  | 1 | **1.9.5.2.2.1 HALL D BARREL CALORIMETER** |  | 2010-03-02 | 2013-08-30 |  |  |  |  |  |  |  |  |  |  |  |  |  |  |  |  |  |  |  |  |  |  |  |  |  |  |  |  |  |  |
| 195221015 |  | Bcal Module Construction Manager Phase 2 (LOE) | 209d | 2010-03-02 | 2010-12-31 | 15221195 | 84d | 0d | PROCUREMENT<$50K 60 NO ESCALATION; PROCUREMENT>$50K 69 NO ESCALATION | 81,180 | CHUDAKOV | 1 | 1 | EUGENE C |  |  | D | APP | 5221B | 09-043 | 10-001A | 10-034 | 11-006 | 11-026 | 12-021F | 12-054F |  |  |  |  |  |  |  |  |  |
| 195221030 |  | Module #9 Matrix Fabrication | 44d | 2010-03-02 | 2010-04-30 | 15221050, 9-100M FS+98d | 595d | 511d | PROCUREMENT>$50K 69 NO ESCALATION | 12,842 | CHUDAKOV | 1 | 1 | EUGENE C |  |  | D | APP | 5221B | 09-043 | 10-001A | 10-034 | 11-006 | 11-026 | 12-021F | 12-054F | 09-014 |  |  |  |  |  |  |  |  |
| 195221035 |  | Module #9 Machining and Shipping | 93d | 2010-03-02 | 2010-07-12 | 9-100M FS+98d | 541d | 0d | PROCUREMENT>$50K 69 NO ESCALATION | 4,607 | CHUDAKOV | 1 | 1 | EUGENE C |  |  | D | APP | 5221B | 09-043 | 10-001A | 10-034 | 11-006 | 11-026 | 12-021F | 12-054F |  |  |  |  |  |  |  |  |  |
| 195221040 |  | Module #10 Matrix Fabrication | 44d | 2010-03-02 | 2010-04-30 | 9-100M FS+98d | 595d | 511d | PROCUREMENT>$50K 69 NO ESCALATION | 12,842 | CHUDAKOV | 1 | 1 | EUGENE C |  |  | D | APP | 5221B | 09-043 | 10-001A | 10-034 | 11-006 | 11-026 | 12-021F | 12-054F |  |  |  |  |  |  |  |  |  |
| 195221045 |  | Module #10 Machining and Shipping | 93d | 2010-03-02 | 2010-07-12 | 9-100M FS+98d | 541d | 0d | PROCUREMENT>$50K 69 NO ESCALATION | 4,607 | CHUDAKOV | 1 | 1 | EUGENE C |  |  | D | APP | 5221B | 09-043 | 10-001A | 10-034 | 11-006 | 11-026 | 12-021F | 12-054F |  |  |  |  |  |  |  |  |  |
| 195221050 |  | Module #11 Matrix Fabrication | 70d | 2010-03-02 | 2010-06-08 | 9-100M FS+98d | 569d | 485d | PROCUREMENT>$50K 69 NO ESCALATION | 12,842 | CHUDAKOV | 1 | 1 | EUGENE C |  |  | D | APP | 5221B | 09-043 | 10-001A | 10-034 | 11-006 | 11-026 | 12-021F | 12-054F |  |  |  |  |  |  |  |  |  |
| 195221055 |  | Module #11 Machining and Shipping | 93d | 2010-03-02 | 2010-07-12 | 9-100M FS+98d | 541d | 0d | PROCUREMENT>$50K 69 NO ESCALATION | 4,607 | CHUDAKOV | 1 | 1 | EUGENE C |  |  | D | APP | 5221B | 09-043 | 10-001A | 10-034 | 11-006 | 11-026 | 12-021F | 12-054F | 09-014 |  |  |  |  |  |  |  |  |
| 195221060 |  | Module #12 Matrix Fabrication | 70d | 2010-03-02 | 2010-06-08 | 9-100M FS+98d | 569d | 485d | PROCUREMENT>$50K 69 NO ESCALATION | 12,842 | CHUDAKOV | 1 | 1 | EUGENE C |  |  | D | APP | 5221B | 09-043 | 10-001A | 10-034 | 11-006 | 11-026 | 12-021F | 12-054F | 09-014 |  |  |  |  |  |  |  |  |
| 195221065 |  | Module #12 Machining and Shipping | 93d | 2010-03-02 | 2010-07-12 | 9-100M FS+98d | 541d | 0d | PROCUREMENT>$50K 69 NO ESCALATION | 4,607 | CHUDAKOV | 1 | 1 | EUGENE C |  |  | D | APP | 5221B | 09-043 | 10-001A | 10-034 | 11-006 | 11-026 | 12-021F | 12-054F | 09-014 |  |  |  |  |  |  |  |  |
| 195221070 |  | Module #13 Matrix Fabrication | 96d | 2010-03-02 | 2010-07-15 | 9-100M FS+98d | 543d | 459d | PROCUREMENT>$50K 69 NO ESCALATION | 12,842 | CHUDAKOV | 1 | 1 | EUGENE C |  |  | D | APP | 5221B | 09-043 | 10-001A | 10-034 | 11-006 | 11-026 | 12-021F | 12-054F | 09-014 | 08-016 |  |  |  |  |  |  |  |
| 195221075 |  | Module #13 Machining and Shipping | 146d | 2010-03-02 | 2010-09-24 | 9-100M FS+98d | 488d | 0d | PROCUREMENT>$50K 69 NO ESCALATION | 4,607 | CHUDAKOV | 1 | 1 | EUGENE C |  |  | D | APP | 5221B | 09-043 | 10-001A | 10-034 | 11-006 | 11-026 | 12-021F | 12-054F | 09-014 |  |  |  |  |  |  |  |  |
| 195221080 |  | Module #14 Matrix Fabrication | 96d | 2010-03-02 | 2010-07-15 | 9-100M FS+98d | 543d | 459d | PROCUREMENT>$50K 69 NO ESCALATION | 12,842 | CHUDAKOV | 1 | 1 | EUGENE C |  |  | D | APP | 5221B | 09-043 | 10-001A | 10-034 | 11-006 | 11-026 | 12-021F | 12-054F | 09-014 | 08-016 |  |  |  |  |  |  |  |
| 195221085 |  | Module #14 Machining and Shipping | 146d | 2010-03-02 | 2010-09-24 | 9-100M FS+98d | 488d | 0d | PROCUREMENT>$50K 69 NO ESCALATION | 4,607 | CHUDAKOV | 1 | 1 | EUGENE C |  |  | D | APP | 5221B | 09-043 | 10-001A | 10-034 | 11-006 | 11-026 | 12-021F | 12-054F | 09-014 |  |  |  |  |  |  |  |  |
| 195221090 |  | Module #15 Matrix Fabrication | 123d | 2010-03-02 | 2010-08-23 | 9-100M FS+98d | 516d | 432d | PROCUREMENT>$50K 69 NO ESCALATION | 12,842 | CHUDAKOV | 1 | 1 | EUGENE C |  |  | D | APP | 5221B | 09-043 | 10-001A | 10-034 | 11-006 | 11-026 | 12-021F | 12-054F | 09-014 |  |  |  |  |  |  |  |  |
| 195221095 |  | Module #15 Machining and Shipping | 146d | 2010-03-02 | 2010-09-24 | 9-100M FS+98d | 488d | 0d | PROCUREMENT>$50K 69 NO ESCALATION | 4,607 | CHUDAKOV | 1 | 1 | EUGENE C |  |  | D | APP | 5221B | 09-043 | 10-001A | 10-034 | 11-006 | 11-026 | 12-021F | 12-054F | 09-014 |  |  |  |  |  |  |  |  |
| 195221100 |  | Module #16 Matrix Fabrication | 123d | 2010-03-02 | 2010-08-23 | 9-100M FS+98d | 516d | 432d | PROCUREMENT>$50K 69 NO ESCALATION | 12,842 | CHUDAKOV | 1 | 1 | EUGENE C |  |  | D | APP | 5221B | 09-043 | 10-001A | 10-034 | 11-006 | 11-026 | 12-021F | 12-054F | 09-014 |  |  |  |  |  |  |  |  |
| 195221105 |  | Module #16 Machining and Shipping | 146d | 2010-03-02 | 2010-09-24 | 9-100M FS+98d | 488d | 0d | PROCUREMENT>$50K 69 NO ESCALATION | 4,607 | CHUDAKOV | 1 | 1 | EUGENE C |  |  | D | APP | 5221B | 09-043 | 10-001A | 10-034 | 11-006 | 11-026 | 12-021F | 12-054F | 09-014 |  |  |  |  |  |  |  |  |
| 195221110 |  | Module #17 Matrix Fabrication | 149d | 2010-03-02 | 2010-09-29 | 9-100M FS+98d | 490d | 406d | PROCUREMENT>$50K 69 NO ESCALATION | 12,842 | CHUDAKOV | 1 | 1 | EUGENE C |  |  | D | APP | 5221B | 09-043 | 10-001A | 10-034 | 11-006 | 11-026 | 12-021F | 12-054F | 09-014 |  |  |  |  |  |  |  |  |
| 195221115 |  | Module #17 Machining and Shipping | 198d | 2010-03-02 | 2010-12-09 | 9-100M FS+98d | 436d | 9d | PROCUREMENT>$50K 69 NO ESCALATION | 4,607 | CHUDAKOV | 1 | 1 | EUGENE C |  |  | D | APP | 5221B | 09-043 | 10-001A | 10-034 | 11-006 | 11-026 | 12-021F | 12-054F |  |  |  |  |  |  |  |  |  |
| 195221120 |  | Module #18 Matrix Fabrication | 149d | 2010-03-02 | 2010-09-29 | 9-100M FS+98d | 490d | 406d | PROCUREMENT>$50K 69 NO ESCALATION | 12,842 | CHUDAKOV | 1 | 1 | EUGENE C |  |  | D | APP | 5221B | 09-043 | 10-001A | 10-034 | 11-006 | 11-026 | 12-021F | 12-054F | 09-014 |  |  |  |  |  |  |  |  |
| 195221125 |  | Module #18 Machining and Shipping | 198d | 2010-03-02 | 2010-12-09 | 9-100M FS+98d | 436d | 9d | PROCUREMENT>$50K 69 NO ESCALATION | 4,607 | CHUDAKOV | 1 | 1 | EUGENE C |  |  | D | APP | 5221B | 09-043 | 10-001A | 10-034 | 11-006 | 11-026 | 12-021F | 12-054F |  |  |  |  |  |  |  |  |  |
| 195221130 |  | Module #19 Matrix Fabrication | 176d | 2010-03-02 | 2010-11-05 | 9-100M FS+98d | 463d | 379d | PROCUREMENT>$50K 69 NO ESCALATION | 12,842 | CHUDAKOV | 1 | 1 | EUGENE C |  |  | D | APP | 5221B | 09-043 | 10-001A | 10-034 | 11-006 | 11-026 | 12-021F | 12-054F |  |  |  |  |  |  |  |  |  |
| 195221135 |  | Module #19 Machining and Shipping | 207d | 2010-03-02 | 2010-12-29 | 9-100M FS+98d | 427d | 0d | PROCUREMENT>$50K 69 NO ESCALATION | 4,607 | CHUDAKOV | 1 | 1 | EUGENE C |  |  | D | APP | 5221B | 09-043 | 10-001A | 10-034 | 11-006 | 11-026 | 12-021F | 12-054F |  |  |  |  |  |  |  |  |  |
| 195221140 |  | Module #20 Matrix Fabrication | 176d | 2010-03-02 | 2010-11-05 | 9-100M FS+98d | 463d | 379d | PROCUREMENT>$50K 69 NO ESCALATION | 12,842 | CHUDAKOV | 1 | 1 | EUGENE C |  |  | D | APP | 5221B | 09-043 | 10-001A | 10-034 | 11-006 | 11-026 | 12-021F | 12-054F |  |  |  |  |  |  |  |  |  |
| 195221145 |  | Module #20 Machining and Shipping | 198d | 2010-03-02 | 2010-12-09 | 9-100M FS+98d | 436d | 9d | PROCUREMENT>$50K 69 NO ESCALATION | 4,607 | CHUDAKOV | 1 | 1 | EUGENE C |  |  | D | APP | 5221B | 09-043 | 10-001A | 10-034 | 11-006 | 11-026 | 12-021F | 12-054F |  |  | 1 |  |  |  |  |  |  |
| 195221150 |  | Module #21 Matrix Fabrication | 201d | 2010-03-02 | 2010-12-14 | 9-100M FS+98d | 438d | 354d | PROCUREMENT>$50K 69 NO ESCALATION | 12,842 | CHUDAKOV | 1 | 1 | EUGENE C |  |  | D | APP | 5221B | 09-043 | 10-001A | 10-034 | 11-006 | 11-026 | 12-021F | 12-054F | 09-014 |  |  |  |  |  |  |  |  |
| 195221155 |  | Module #21 Machining and Shipping | 244d | 2010-03-02 | 2011-02-23 | 9-100M FS+98d | 390d | 0d | PROCUREMENT>$50K 69 NO ESCALATION | 4,607 | CHUDAKOV | 1 | 1 | EUGENE C |  |  | D | APP | 5221B | 09-043 | 10-001A | 10-034 | 11-006 | 11-026 | 12-021F | 12-054F |  |  | 1 | 09-027 | 09-027 |  |  |  |  |
| 195221160 |  | Module #22 Matrix Fabrication | 201d | 2010-03-02 | 2010-12-14 | 9-100M FS+98d | 438d | 354d | PROCUREMENT>$50K 69 NO ESCALATION | 12,842 | CHUDAKOV | 1 | 1 | EUGENE C |  |  | D | APP | 5221B | 09-043 | 10-001A | 10-034 | 11-006 | 11-026 | 12-021F | 12-054F |  |  | 1 | 09-027 | 09-027 |  |  |  |  |
| 195221165 |  | Module #22 Machining and Shipping | 244d | 2010-03-02 | 2011-02-23 | 9-100M FS+98d | 390d | 0d | PROCUREMENT>$50K 69 NO ESCALATION | 4,607 | CHUDAKOV | 1 | 1 | EUGENE C |  |  | D | APP | 5221B | 09-043 | 10-001A | 10-034 | 11-006 | 11-026 | 12-021F | 12-054F |  |  | 1 | 09-027 | 09-027 |  |  |  |  |
| 195221170 |  | Module #23 Matrix Fabrication | 221d | 2010-03-02 | 2011-01-20 | 9-100M FS+98d | 418d | 334d | PROCUREMENT>$50K 69 NO ESCALATION | 12,842 | CHUDAKOV | 1 | 1 | EUGENE C |  |  | D | APP | 5221B | 09-043 | 10-001A | 10-034 | 11-006 | 11-026 | 12-021F | 12-054F |  |  | 1 |  |  |  |  |  |  |
| 195221175 |  | Module #23 Machining and Shipping | 244d | 2010-03-02 | 2011-02-23 | 9-100M FS+98d | 390d | 0d | PROCUREMENT>$50K 69 NO ESCALATION | 4,607 | CHUDAKOV | 1 | 1 | EUGENE C |  |  | D | APP | 5221B | 09-043 | 10-001A | 10-034 | 11-006 | 11-026 | 12-021F | 12-054F |  |  | 1 | 09-027 | 09-027 |  |  |  |  |
| 195221180 |  | Module #24 Matrix Fabrication | 221d | 2010-03-02 | 2011-01-20 | 9-100M FS+98d | 418d | 334d | PROCUREMENT>$50K 69 NO ESCALATION | 12,842 | CHUDAKOV | 1 | 1 | EUGENE C |  |  | D | APP | 5221B | 09-043 | 10-001A | 10-034 | 11-006 | 11-026 | 12-021F | 12-054F |  |  | 1 |  |  |  |  |  |  |
| 195221185 |  | Module #24 Machining and Shipping | 244d | 2010-03-02 | 2011-02-23 | 9-100M FS+98d | 390d | 0d | PROCUREMENT>$50K 69 NO ESCALATION | 4,607 | CHUDAKOV | 1 | 1 | EUGENE C |  |  | D | APP | 5221B | 09-043 | 10-001A | 10-034 | 11-006 | 11-026 | 12-021F | 12-054F |  |  | 1 | 09-027 | 09-027 |  |  |  |  |
| 195221000 |  | Proc SciFi Mods P-3 FY11 October Delivery | 21d | 2010-10-01 | 2010-10-29 | 15221018K | 220d | 0d | PROCUREMENT<$50K 60 NO ESCALATION; PROCUREMENT>$50K 69 NO ESCALATION | 104,886.31 | CHUDAKOV | 1 | 1 | EUGENE C |  |  | D | APP | 5221A |  |  | 10-034 | 11-006 | 11-026 | 12-021F | 12-054F |  |  | 1 |  |  | CVL | 07-024 | 09-004 | 09-052 |
| 195221001 |  | Proc SciFi Mods P-3 FY11 November Delivery | 41d | 2010-10-01 | 2010-11-30 | 195221000 FS-21d | 220d | 0d | PROCUREMENT<$50K 60 NO ESCALATION; PROCUREMENT>$50K 69 NO ESCALATION | 104,886.31 | CHUDAKOV | 1 | 1 | EUGENE C |  |  | D | APP | 5221A |  |  | 10-034 | 11-006 | 11-026 | 12-021F | 12-054F |  |  | 1 |  |  | CVL |  |  |  |
| 195221020 |  | Bcal Module Construction Manager Phase 3 (LOE) | 247d | 2011-01-04 | 2011-12-30 | 195221015 | 84d | 0d | PROCUREMENT>$50K 69 NO ESCALATION; PROCUREMENT<$50K 60 NO ESCALATION | 95,832 | CHUDAKOV | 1 | 1 | EUGENE C |  |  | D | APP | 5221B | 09-043 | 10-001A | 10-034 | 11-006 | 11-026 | 12-021F | 12-054F |  |  |  |  |  |  |  |  |  |
| 195221190 |  | Module #25 Matrix Fabrication | 38d | 2011-01-04 | 2011-02-28 | 9-110M FS+59d | 392d | 308d | PROCUREMENT>$50K 69 NO ESCALATION | 12,842 | CHUDAKOV | 1 | 1 | EUGENE C |  |  | D | APP | 5221B | 09-043 | 10-001A | 10-034 | 11-006 | 11-026 | 12-021F | 12-054F | 09-014 |  |  |  |  |  |  |  |  |
| 195221195 |  | Module #25 Machining and Shipping | 89d | 2011-01-04 | 2011-05-10 | 9-110M FS+59d | 336d | 0d | PROCUREMENT>$50K 69 NO ESCALATION | 4,607 | CHUDAKOV | 1 | 1 | EUGENE C |  |  | D | APP | 5221B | 09-043 | 10-001A | 10-034 | 11-006 | 11-026 | 12-021F | 12-054F | 09-014 |  |  |  |  |  |  |  |  |
| 195221200 |  | Module #26 Matrix Fabrication | 38d | 2011-01-04 | 2011-02-28 | 9-110M FS+59d | 392d | 308d | PROCUREMENT>$50K 69 NO ESCALATION | 12,842 | CHUDAKOV | 1 | 1 | EUGENE C |  |  | D | APP | 5221B | 09-043 | 10-001A | 10-034 | 11-006 | 11-026 | 12-021F | 12-054F | 09-014 |  |  |  |  |  |  |  |  |
| 195221205 |  | Module #26 Machining and Shipping | 89d | 2011-01-04 | 2011-05-10 | 9-110M FS+59d | 336d | 0d | PROCUREMENT>$50K 69 NO ESCALATION | 4,607 | CHUDAKOV | 1 | 1 | EUGENE C |  |  | D | APP | 5221B | 09-043 | 10-001A | 10-034 | 11-006 | 11-026 | 12-021F | 12-054F | 09-014 |  |  |  |  |  |  |  |  |
| 195221210 |  | Module #27 Matrix Fabrication | 65d | 2011-01-04 | 2011-04-06 | 9-110M FS+59d | 365d | 281d | PROCUREMENT>$50K 69 NO ESCALATION | 12,842 | CHUDAKOV | 1 | 1 | EUGENE C |  |  | D | APP | 5221B | 09-043 | 10-001A | 10-034 | 11-006 | 11-026 | 12-021F | 12-054F | 09-014 |  |  |  |  |  |  |  |  |
| 195221215 |  | Module #27 Machining and Shipping | 89d | 2011-01-04 | 2011-05-10 | 9-110M FS+59d | 336d | 0d | PROCUREMENT>$50K 69 NO ESCALATION | 4,607 | CHUDAKOV | 1 | 1 | EUGENE C |  |  | D | APP | 5221B | 09-043 | 10-001A | 10-034 | 11-006 | 11-026 | 12-021F | 12-054F |  |  |  |  |  |  |  |  |  |
| 195221220 |  | Module #28 Matrix Fabrication | 65d | 2011-01-04 | 2011-04-06 | 9-110M FS+59d | 365d | 281d | PROCUREMENT>$50K 69 NO ESCALATION | 12,842 | CHUDAKOV | 1 | 1 | EUGENE C |  |  | D | APP | 5221B | 09-043 | 10-001A | 10-034 | 11-006 | 11-026 | 12-021F | 12-054F | 09-014 |  |  |  |  |  |  |  |  |
| 195221225 |  | Module #28 Machining and Shipping | 89d | 2011-01-04 | 2011-05-10 | 9-110M FS+59d | 336d | 0d | PROCUREMENT>$50K 69 NO ESCALATION | 4,607 | CHUDAKOV | 1 | 1 | EUGENE C |  |  | D | APP | 5221B | 09-043 | 10-001A | 10-034 | 11-006 | 11-026 | 12-021F | 12-054F |  |  |  |  |  |  |  |  |  |
| 195221230 |  | Module #29 Matrix Fabrication | 92d | 2011-01-04 | 2011-05-13 | 9-110M FS+59d | 338d | 254d | PROCUREMENT>$50K 69 NO ESCALATION | 12,842 | CHUDAKOV | 1 | 1 | EUGENE C |  |  | D | APP | 5221B | 09-043 | 10-001A | 10-034 | 11-006 | 11-026 | 12-021F | 12-054F |  |  |  |  |  |  |  |  |  |
| 195221235 |  | Module #29 Machining and Shipping | 141d | 2011-01-04 | 2011-07-25 | 9-110M FS+59d | 284d | 0d | PROCUREMENT>$50K 69 NO ESCALATION | 4,607 | CHUDAKOV | 1 | 1 | EUGENE C |  |  | D | APP | 5221B | 09-043 | 10-001A | 10-034 | 11-006 | 11-026 | 12-021F | 12-054F |  |  |  |  |  |  |  |  |  |
| 195221240 |  | Module #30 Matrix Fabrication | 92d | 2011-01-04 | 2011-05-13 | 9-110M FS+59d | 338d | 254d | PROCUREMENT>$50K 69 NO ESCALATION | 12,842 | CHUDAKOV | 1 | 1 | EUGENE C |  |  | D | APP | 5221B | 09-043 | 10-001A | 10-034 | 11-006 | 11-026 | 12-021F | 12-054F |  |  |  |  |  |  |  |  |  |
| 195221245 |  | Module #30 Machining and Shipping | 141d | 2011-01-04 | 2011-07-25 | 9-110M FS+59d | 284d | 0d | PROCUREMENT>$50K 69 NO ESCALATION | 4,607 | CHUDAKOV | 1 | 1 | EUGENE C |  |  | D | APP | 5221B | 09-043 | 10-001A | 10-034 | 11-006 | 11-026 | 12-021F | 12-054F |  |  | 1 |  |  |  |  |  |  |
| 195221250 |  | Module #31 Matrix Fabrication | 118d | 2011-01-04 | 2011-06-21 | 9-110M FS+59d | 312d | 228d | PROCUREMENT>$50K 69 NO ESCALATION | 12,842 | CHUDAKOV | 1 | 1 | EUGENE C |  |  | D | APP | 5221B | 09-043 | 10-001A | 10-034 | 11-006 | 11-026 | 12-021F | 12-054F | 09-014 |  |  |  |  |  |  |  |  |
| 195221255 |  | Module #31 Machining and Shipping | 141d | 2011-01-04 | 2011-07-25 | 9-110M FS+59d | 284d | 0d | PROCUREMENT>$50K 69 NO ESCALATION | 4,607 | CHUDAKOV | 1 | 1 | EUGENE C |  |  | D | APP | 5221B | 09-043 | 10-001A | 10-034 | 11-006 | 11-026 | 12-021F | 12-054F |  |  | 1 | 09-027 | 09-027 |  |  |  |  |
| 195221260 |  | Module #32 Matrix Fabrication | 118d | 2011-01-04 | 2011-06-21 | 9-110M FS+59d | 312d | 228d | PROCUREMENT>$50K 69 NO ESCALATION | 12,842 | CHUDAKOV | 1 | 1 | EUGENE C |  |  | D | APP | 5221B | 09-043 | 10-001A | 10-034 | 11-006 | 11-026 | 12-021F | 12-054F |  |  | 1 | 09-027 | 09-027 |  |  |  |  |
| 195221265 |  | Module #32 Machining and Shipping | 141d | 2011-01-04 | 2011-07-25 | 9-110M FS+59d | 284d | 0d | PROCUREMENT>$50K 69 NO ESCALATION | 4,607 | CHUDAKOV | 1 | 1 | EUGENE C |  |  | D | APP | 5221B | 09-043 | 10-001A | 10-034 | 11-006 | 11-026 | 12-021F | 12-054F |  |  | 1 | 09-027 | 09-027 |  |  |  |  |
| 195221270 |  | Module #33 Matrix Fabrication | 144d | 2011-01-04 | 2011-07-28 | 9-110M FS+59d | 286d | 202d | PROCUREMENT>$50K 69 NO ESCALATION | 12,842 | CHUDAKOV | 1 | 1 | EUGENE C |  |  | D | APP | 5221B | 09-043 | 10-001A | 10-034 | 11-006 | 11-026 | 12-021F | 12-054F |  |  | 1 |  |  |  |  |  |  |
| 195221275 |  | Module #33 Machining and Shipping | 194d | 2011-01-04 | 2011-10-07 | 9-110M FS+59d | 231d | 0d | PROCUREMENT>$50K 69 NO ESCALATION | 4,607 | CHUDAKOV | 1 | 1 | EUGENE C |  |  | D | APP | 5221B | 09-043 | 10-001A | 10-034 | 11-006 | 11-026 | 12-021F | 12-054F |  |  | 1 | 09-027 | 09-027 |  |  |  |  |
| 195221285 |  | Module #34 Matrix Fabrication | 144d | 2011-01-04 | 2011-07-28 | 9-110M FS+59d | 286d | 202d | PROCUREMENT>$50K 69 NO ESCALATION | 12,842 | CHUDAKOV | 1 | 1 | EUGENE C |  |  | D | APP | 5221B | 09-043 | 10-001A | 10-034 | 11-006 | 11-026 | 12-021F | 12-054F |  |  | 1 |  |  |  |  |  |  |
| 195221290 |  | Module #34 Machining and Shipping | 194d | 2011-01-04 | 2011-10-07 | 9-110M FS+59d | 231d | 0d | PROCUREMENT>$50K 69 NO ESCALATION | 4,607 | CHUDAKOV | 1 | 1 | EUGENE C |  |  | D | APP | 5221B | 09-043 | 10-001A | 10-034 | 11-006 | 11-026 | 12-021F | 12-054F |  |  | 1 | 09-027 | 09-027 |  |  |  |  |
| 195221295 |  | Module #35 Matrix Fabrication | 171d | 2011-01-04 | 2011-09-06 | 9-110M FS+59d | 259d | 175d | PROCUREMENT>$50K 69 NO ESCALATION | 12,842 | CHUDAKOV | 1 | 1 | EUGENE C |  |  | D | APP | 5221B | 09-043 | 10-001A | 10-034 | 11-006 | 11-026 | 12-021F | 12-054F | 09-014 |  |  |  |  |  |  |  |  |
| 195221300 |  | Module #35 Machining and Shipping | 194d | 2011-01-04 | 2011-10-07 | 9-110M FS+59d | 231d | 0d | PROCUREMENT>$50K 69 NO ESCALATION | 4,607 | CHUDAKOV | 1 | 1 | EUGENE C |  |  | D | APP | 5221B | 09-043 | 10-001A | 10-034 | 11-006 | 11-026 | 12-021F | 12-054F | 09-014 |  |  |  |  |  |  |  |  |
| 195221305 |  | Module #36 Matrix Fabrication | 171d | 2011-01-04 | 2011-09-06 | 9-110M FS+59d | 259d | 175d | PROCUREMENT>$50K 69 NO ESCALATION | 12,842 | CHUDAKOV | 1 | 1 | EUGENE C |  |  | D | APP | 5221B | 09-043 | 10-001A | 10-034 | 11-006 | 11-026 | 12-021F | 12-054F | 09-014 |  |  |  |  |  |  |  |  |
| 195221310 |  | Module #36 Machining and Shipping | 194d | 2011-01-04 | 2011-10-07 | 9-110M FS+59d | 231d | 0d | PROCUREMENT>$50K 69 NO ESCALATION | 4,607 | CHUDAKOV | 1 | 1 | EUGENE C |  |  | D | APP | 5221B | 09-043 | 10-001A | 10-034 | 11-006 | 11-026 | 12-021F | 12-054F | 09-014 |  |  |  |  |  |  |  |  |
| 195221315 |  | Module #37 Matrix Fabrication | 197d | 2011-01-04 | 2011-10-12 | 9-110M FS+59d | 233d | 149d | PROCUREMENT>$50K 69 NO ESCALATION | 12,842 | CHUDAKOV | 1 | 1 | EUGENE C |  |  | D | APP | 5221B | 09-043 | 10-001A | 10-034 | 11-006 | 11-026 | 12-021F | 12-054F | 09-014 |  |  |  |  |  |  |  |  |
| 195221320 |  | Module #37 Machining and Shipping | 245d | 2011-01-04 | 2011-12-21 | 9-110M FS+59d | 180d | 0d | PROCUREMENT>$50K 69 NO ESCALATION | 4,607 | CHUDAKOV | 1 | 1 | EUGENE C |  |  | D | APP | 5221B | 09-043 | 10-001A | 10-034 | 11-006 | 11-026 | 12-021F | 12-054F |  |  |  |  |  |  |  |  |  |
| 195221325 |  | Module #38 Matrix Fabrication | 197d | 2011-01-04 | 2011-10-12 | 9-110M FS+59d | 233d | 149d | PROCUREMENT>$50K 69 NO ESCALATION | 12,842 | CHUDAKOV | 1 | 1 | EUGENE C |  |  | D | APP | 5221B | 09-043 | 10-001A | 10-034 | 11-006 | 11-026 | 12-021F | 12-054F | 09-014 |  |  |  |  |  |  |  |  |
| 195221330 |  | Module #38 Machining and Shipping | 245d | 2011-01-04 | 2011-12-21 | 9-110M FS+59d | 180d | 0d | PROCUREMENT>$50K 69 NO ESCALATION | 4,607 | CHUDAKOV | 1 | 1 | EUGENE C |  |  | D | APP | 5221B | 09-043 | 10-001A | 10-034 | 11-006 | 11-026 | 12-021F | 12-054F |  |  |  |  |  |  |  |  |  |
| 195221335 |  | Module #39 Matrix Fabrication | 224d | 2011-01-04 | 2011-11-18 | 9-110M FS+59d | 206d | 122d | PROCUREMENT>$50K 69 NO ESCALATION | 12,842 | CHUDAKOV | 1 | 1 | EUGENE C |  |  | D | APP | 5221B | 09-043 | 10-001A | 10-034 | 11-006 | 11-026 | 12-021F | 12-054F |  |  |  |  |  |  |  |  |  |
| 195221340 |  | Module #39 Machining and Shipping | 245d | 2011-01-04 | 2011-12-21 | 9-110M FS+59d | 180d | 0d | PROCUREMENT>$50K 69 NO ESCALATION | 4,607 | CHUDAKOV | 1 | 1 | EUGENE C |  |  | D | APP | 5221B | 09-043 | 10-001A | 10-034 | 11-006 | 11-026 | 12-021F | 12-054F |  |  |  |  |  |  |  |  |  |

Notes:
- 195221000: Corrective Actions: Deleted FY12 funding predecessor since it is applied to this activities / successor.
- 195221001: Corrective Actions: Deleted FY12 funding predecessor since it is applied to this activities / successor.

| ID | Activity | Type | Duration | Start | Finish | Predecessors | Total float | Free float | Resources | Cost | RESP - Responsibility | STRT%COMP for CM EVM | FNSH%COMP for CM EVM | HALL D Related Milestones | Advance Purchase Plan > 500K | CAM RESPONSIBLE | 12 GEV MAJOR PROCUREMENT CATAGORY | CR 09-043 | CR 10-001 | CR 10-034 | CR 11-006 | CR 11-026 | CR 12-021 | CR 12-054 | 12 GeV 1st level Critical Path | CR 09-014 | CR 09-027 | CR 09-027 Repair | CR 11-040 | Milestone Level | CR 13-014 | ReBaseline Actuals Adjustment |
| --- | --- | --- | --- | --- | --- | --- | --- | --- | --- | --- | --- | --- | --- | --- | --- | --- | --- | --- | --- | --- | --- | --- | --- | --- | --- | --- | --- | --- | --- | --- | --- | --- |
| 195221345 | Module #40 Matrix Fabrication |  | 224d | 2011-01-04 | 2011-11-18 | 9-110M FS+59d | 206d | 122d | PROCUREMENT>$50K 69 NO ESCALATION | 12,842 | CHUDAKOV | 1 | 1 | D | APP | EUGENE C | 5221B | 09-043 | 10-001A | 10-034 | 11-006 | 11-026 | 12-021F | 12-054F |  |  |  |  |  |  |  |  |
| 195221350 | Module #40 Machining and Shipping |  | 245d | 2011-01-04 | 2011-12-21 | 9-110M FS+59d | 180d | 0d | PROCUREMENT>$50K 69 NO ESCALATION | 4,607 | CHUDAKOV | 1 | 1 | D | APP | EUGENE C | 5221B | 09-043 | 10-001A | 10-034 | 11-006 | 11-026 | 12-021F | 12-054F | 1 |  |  |  |  |  |  |  |
| 195221355 | Module #41 Matrix Fabrication |  | 246d | 2011-01-04 | 2011-12-29 | 9-110M FS+59d | 184d | 100d | PROCUREMENT>$50K 69 NO ESCALATION | 12,842 | CHUDAKOV | 1 | 1 | D | APP | EUGENE C | 5221B | 09-043 | 10-001A | 10-034 | 11-006 | 11-026 | 12-021F | 12-054F |  | 09-014 |  |  |  |  |  |  |
| 195221360 | Module #41 Machining and Shipping |  | 292d | 2011-01-04 | 2012-03-07 | 9-110M FS+59d | 133d | 0d | PROCUREMENT>$50K 69 NO ESCALATION | 4,607 | CHUDAKOV | 1 | 1 | D | APP | EUGENE C | 5221B | 09-043 | 10-001A | 10-034 | 11-006 | 11-026 | 12-021F | 12-054F | 1 |  | 09-027 | 09-027 |  |  |  |  |
| 195221365 | Module #42 Matrix Fabrication |  | 246d | 2011-01-04 | 2011-12-29 | 9-110M FS+59d | 184d | 100d | PROCUREMENT>$50K 69 NO ESCALATION | 12,842 | CHUDAKOV | 1 | 1 | D | APP | EUGENE C | 5221B | 09-043 | 10-001A | 10-034 | 11-006 | 11-026 | 12-021F | 12-054F | 1 |  | 09-027 | 09-027 |  |  |  |  |
| 195221370 | Module #42 Machining and Shipping |  | 292d | 2011-01-04 | 2012-03-07 | 9-110M FS+59d | 133d | 0d | PROCUREMENT>$50K 69 NO ESCALATION | 4,607 | CHUDAKOV | 1 | 1 | D | APP | EUGENE C | 5221B | 09-043 | 10-001A | 10-034 | 11-006 | 11-026 | 12-021F | 12-054F | 1 |  | 09-027 | 09-027 |  |  |  |  |
| 195221450 | USM Peg Point # 1 Initial Order Placed |  | 36d | 2011-06-09 | 2011-07-29 | 9-110M FS+168d | 312d | 0d | PROCUREMENT>$50K 69 NO ESCALATION; PROCUREMENT<$50K 60 NO ESCALATION | 282,500 | CHUDAKOV | 1 | 1 | D | APP | EUGENE C | 5221B | 09-043 | 10-001A | 10-034 | 11-006 | 11-026 |  |  | 1 |  | 09-027 | 09-027 | 11-040 |  |  |  |
| 195221455 | USM Peg Point # 2 On-site Review passed |  | 121d | 2011-06-09 | 2011-11-30 | 195221450 FS-36d | 312d | 0d | PROCUREMENT>$50K 69 NO ESCALATION | 282,500 | CHUDAKOV | 1 | 1 | D | APP | EUGENE C | 5221B | 09-043 | 10-001A | 10-034 | 11-006 | 11-026 |  |  | 1 |  | 09-027 | 09-027 | 11-040 |  |  |  |
| 195221460 | USM Peg Point # 3 Batch #1 Arrival at USM |  | 138d | 2011-06-09 | 2011-12-30 | 195221455 FS-121d | 312d | 0d | PROCUREMENT>$50K 69 NO ESCALATION | 282,500 | CHUDAKOV | 1 | 1 | D | APP | EUGENE C | 5221B | 09-043 | 10-001A | 10-034 | 11-006 | 11-026 |  |  | 1 |  | 09-027 | 09-027 | 11-040 |  |  |  |
| 195221465 | USM Peg Point # 4 Batch #2 Arrival at USM |  | 158d | 2011-06-09 | 2012-01-31 | 195221460 FS-138d | 312d | 0d | PROCUREMENT>$50K 69 NO ESCALATION | 282,500 | CHUDAKOV | 1 | 1 | D | APP | EUGENE C | 5221B | 09-043 | 10-001A | 10-034 | 11-006 | 11-026 |  |  | 1 |  | 09-027 | 09-027 | 11-040 |  |  |  |
| 195221470 | USM Peg Point # 5 Qty. 500 MPPCs tested and shipped to JLab |  | 158d | 2011-06-09 | 2012-01-31 | 195221465 FS-158d | 312d | 0d | PROCUREMENT>$50K 69 NO ESCALATION | 18,928 | CHUDAKOV | 1 | 1 | D | APP | EUGENE C | 5221B | 09-043 | 10-001A | 10-034 | 11-006 | 11-026 |  |  | 1 |  | 09-027 | 09-027 | 11-040 |  |  |  |
| 195221475 | USM Peg Point # 6 Batch #3 Arrival at USM |  | 178d | 2011-06-09 | 2012-02-29 | 195221470 FS-158d | 312d | 0d | PROCUREMENT>$50K 69 NO ESCALATION | 282,500 | CHUDAKOV | 1 | 1 | D | APP | EUGENE C | 5221B | 09-043 | 10-001A | 10-034 | 11-006 | 11-026 |  |  | 1 |  | 09-027 | 09-027 | 11-040 |  |  |  |
| 195221480 | USM Peg Point # 7 Qty. 500 MPPCs tested and shipped to JLab |  | 178d | 2011-06-09 | 2012-02-29 | 195221475 FS-178d | 312d | 0d | PROCUREMENT>$50K 69 NO ESCALATION | 18,928 | CHUDAKOV | 1 | 1 | D | APP | EUGENE C | 5221B | 09-043 | 10-001A | 10-034 | 11-006 | 11-026 |  |  | 1 |  | 09-027 | 09-027 | 11-040 |  |  |  |
| 195221485 | USM Peg Point # 8 Batch #4 Arrival at USM |  | 200d | 2011-06-09 | 2012-03-30 | 195221480 FS-178d | 312d | 0d | PROCUREMENT>$50K 69 NO ESCALATION | 169,500 | CHUDAKOV | 1 | 1 | D | APP | EUGENE C | 5221B | 09-043 | 10-001A | 10-034 | 11-006 | 11-026 |  |  | 1 |  | 09-027 | 09-027 | 11-040 |  |  |  |
| 195221490 | USM Peg Point # 9 Qty. 500 MPPCs tested and shipped to JLab |  | 200d | 2011-06-09 | 2012-03-30 | 195221485 FS-200d | 312d | 0d | PROCUREMENT>$50K 69 NO ESCALATION | 18,928 | CHUDAKOV | 1 | 1 | D | APP | EUGENE C | 5221B | 09-043 | 10-001A | 10-034 | 11-006 | 11-026 |  |  | 1 |  | 09-027 | 09-027 | 11-040 |  |  |  |
| 195221495 | USM Peg Point # 10 Qty. 500 MPPCs tested and shipped to JLab |  | 221d | 2011-06-09 | 2012-04-30 | 195221490 FS-200d | 312d | 0d | PROCUREMENT>$50K 69 NO ESCALATION | 18,928 | CHUDAKOV | 1 | 1 | D | APP | EUGENE C | 5221B | 09-043 | 10-001A | 10-034 | 11-006 | 11-026 |  |  | 1 |  | 09-027 | 09-027 | 11-040 |  |  |  |
| 195221500 | USM Peg Point # 11 Qty. 500 MPPCs tested and shipped to JLab |  | 243d | 2011-06-09 | 2012-05-31 | 195221495 FS-221d | 312d | 0d | PROCUREMENT>$50K 69 NO ESCALATION | 18,928 | CHUDAKOV | 1 | 1 | D | APP | EUGENE C | 5221B | 09-043 | 10-001A | 10-034 | 11-006 | 11-026 |  |  | 1 |  | 09-027 | 09-027 | 11-040 |  |  |  |
| 195221505 | USM Peg Point # 12 Qty. 300 MPPCs tested and shipped to JLab |  | 263d | 2011-06-09 | 2012-06-29 | 195221500 FS-243d | 312d |  | PROCUREMENT>$50K 69 NO ESCALATION | 11,760 | CHUDAKOV | 1 | 1 | D | APP | EUGENE C | 5221B | 09-043 | 10-001A | 10-034 | 11-006 | 11-026 |  |  | 1 |  | 09-027 | 09-027 | 11-040 |  |  |  |
| 195221025 | Bcal Module Construction Manager Phase 4 (LOE) |  | 99d | 2012-01-03 | 2012-05-22 | 195221020 | 84d | 0d | PROCUREMENT<$50K 60 NO ESCALATION | 36,828 | CHUDAKOV | 1 | 1 | D | APP | EUGENE C | 5221B | 09-043 | 10-001A | 10-034 | 11-006 | 11-026 | 12-021F | 12-054F |  |  |  |  |  |  |  |  |
| 195221375 | Module #43 Matrix Fabrication |  | 21d | 2012-01-04 | 2012-02-02 | 9-120M FS+59d, 15221145, 15221018X | 161d | 77d | PROCUREMENT<$50K 60 NO ESCALATION | 12,842 | CHUDAKOV | 1 | 1 | D | APP | EUGENE C | 5221B | 09-043 | 10-001A | 10-034 | 11-006 | 11-026 | 12-021F | 12-054F | 1 |  |  |  |  |  |  |  |
| 195221380 | Module #43 Machining and Shipping |  | 44d | 2012-01-04 | 2012-03-07 | 9-120M FS+59d | 133d | 0d | PROCUREMENT<$50K 60 NO ESCALATION | 4,607 | CHUDAKOV | 1 | 1 | D | APP | EUGENE C | 5221B | 09-043 | 10-001A | 10-034 | 11-006 | 11-026 | 12-021F | 12-054F | 1 |  | 09-027 | 09-027 |  |  |  |  |
| 195221385 | Module #44 Matrix Fabrication |  | 21d | 2012-01-04 | 2012-02-02 | 9-120M FS+59d | 161d | 77d | PROCUREMENT<$50K 60 NO ESCALATION; PROCUREMENT>$50K 69 NO ESCALATION | 12,842 | CHUDAKOV | 1 | 1 | D | APP | EUGENE C | 5221B | 09-043 | 10-001A | 10-034 | 11-006 | 11-026 | 12-021F | 12-054F | 1 |  |  |  |  |  |  |  |
| 195221390 | Module #44 Machining and Shipping |  | 44d | 2012-01-04 | 2012-03-07 | 9-120M FS+59d | 133d | 0d | PROCUREMENT>$50K 69 NO ESCALATION | 4,607 | CHUDAKOV | 1 | 1 | D | APP | EUGENE C | 5221B | 09-043 | 10-001A | 10-034 | 11-006 | 11-026 | 12-021F | 12-054F | 1 |  | 09-027 | 09-027 |  |  |  |  |
| 195221395 | Module #45 Matrix Fabrication |  | 47d | 2012-01-04 | 2012-03-12 | 9-120M FS+59d | 135d | 51d | PROCUREMENT>$50K 69 NO ESCALATION | 12,842 | CHUDAKOV | 1 | 1 | D | APP | EUGENE C | 5221B | 09-043 | 10-001A | 10-034 | 11-006 | 11-026 | 12-021F | 12-054F | 1 |  |  |  |  |  |  |  |
| 195221400 | Module #45 Machining and Shipping |  | 98d | 2012-01-04 | 2012-05-22 | 9-120M FS+59d | 79d | 0d | PROCUREMENT>$50K 69 NO ESCALATION | 4,607 | CHUDAKOV | 1 | 1 | D | APP | EUGENE C | 5221B | 09-043 | 10-001A | 10-034 | 11-006 | 11-026 | 12-021F | 12-054F | 1 |  | 09-027 | 09-027 |  |  |  |  |
| 195221405 | Module #46 Matrix Fabrication |  | 47d | 2012-01-04 | 2012-03-12 | 9-120M FS+59d | 135d | 51d | PROCUREMENT>$50K 69 NO ESCALATION | 12,842 | CHUDAKOV | 1 | 1 | D | APP | EUGENE C | 5221B | 09-043 | 10-001A | 10-034 | 11-006 | 11-026 | 12-021F | 12-054F | 1 |  |  |  |  |  |  |  |
| 195221410 | Module #46 Machining and Shipping |  | 98d | 2012-01-04 | 2012-05-22 | 9-120M FS+59d | 79d | 0d | PROCUREMENT>$50K 69 NO ESCALATION | 4,607 | CHUDAKOV | 1 | 1 | D | APP | EUGENE C | 5221B | 09-043 | 10-001A | 10-034 | 11-006 | 11-026 | 12-021F | 12-054F | 1 |  | 09-027 | 09-027 |  |  |  |  |
| 195221415 | Module #47 Matrix Fabrication |  | 74d | 2012-01-04 | 2012-04-18 | 9-120M FS+59d | 108d | 24d | PROCUREMENT>$50K 69 NO ESCALATION | 12,842 | CHUDAKOV | 1 | 1 | D | APP | EUGENE C | 5221B | 09-043 | 10-001A | 10-034 | 11-006 | 11-026 | 12-021F | 12-054F | 1 |  |  |  |  |  |  |  |
| 195221420 | Module #47 Machining and Shipping |  | 98d | 2012-01-04 | 2012-05-22 | 9-120M FS+59d | 79d | 0d | PROCUREMENT>$50K 69 NO ESCALATION | 4,607 | CHUDAKOV | 1 | 1 | D | APP | EUGENE C | 5221B | 09-043 | 10-001A | 10-034 | 11-006 | 11-026 | 12-021F | 12-054F | 1 |  | 09-027 | 09-027 |  |  |  |  |
| 195221425 | Module #48 Matrix Fabrication |  | 74d | 2012-01-04 | 2012-04-18 | 9-120M FS+59d | 108d | 24d | PROCUREMENT>$50K 69 NO ESCALATION | 12,842 | CHUDAKOV | 1 | 1 | D | APP | EUGENE C | 5221B | 09-043 | 10-001A | 10-034 | 11-006 | 11-026 | 12-021F | 12-054F | 1 |  |  |  |  |  |  |  |
| 195221430 | Module #48 Machining and Shipping |  | 98d | 2012-01-04 | 2012-05-22 | 9-120M FS+59d | 79d | 0d | PROCUREMENT>$50K 69 NO ESCALATION | 4,607 | CHUDAKOV | 1 | 1 | D | APP | EUGENE C | 5221B | 09-043 | 10-001A | 10-034 | 11-006 | 11-026 | 12-021F | 12-054F | 1 |  | 09-027 | 09-027 |  |  |  |  |
| 195221435M | All Barrel Cal Mods Comptd & Shipped | milestone | 0d | 2012-05-22 | 2012-05-22 | 195221115, 195221050, 195221430, 195221285, 195221100, 195221230, 195221140, 195221320, 195221415, 195221195, 15221205, 15221220, 195221365, 195221120, 195221330, 195221175, 195221185, 195221235, 195221395, 195221375, 195221130, 15221265, 15221225, 195221025, 195221145, 195221170, 195221055, 195221225, 195221340, 195221190, 195221110, 15221275, 195221310, 195221355, 195221350, 195221210, 195221380, 195221245, 195221075, 195221095, 195221125, 195221390, 15221230, 15221240, 15221200, 195221370, 195221275, 195221425, 195221300, 195221410, 195221250, 195221090, 195221295, 195221400, 15221260, 15221055a, 15221255, 15221250, 15221245, 195221325, 195221035, 195221135, 195221220, 195221080, 195221105, 195221290, 195221150, 195221345, 195221200, 195221420, 195221040, 15221055b, 15221215, 195221385, 195221180, 195221335, 195221215, 195221160, 195221030, 195221085, 195221060, 195221065, 195221260, 195221165, 195221255, 195221305, 195221240, 15221235, 15221270, 15221173, 195221270, 195221360, 195221045, 195221070, 195221155, 195221405, 195221265, 195221205, 195221315, 15221210 | 84d | 62d |  |  | CHUDAKOV | 1 | 1 | D | APP | EUGENE C | 5221B | 09-043 |  | 10-034 | 11-006 | 11-026 | 12-021F | 12-054F | 1 |  |  |  |  | 6 |  |  |
| 195221510 | Re-Baseline Actuals Adjustment |  | 1d | 2013-08-30 | 2013-08-30 | 9-130M FS+227d | 20d |  | PROCUREMENT>$50K 69 NO ESCALATION | -1,032.62 | CHUDAKOV | 1 | 1 |  |  | EUGENE C |  |  |  |  |  |  |  |  |  |  |  |  |  |  | 13-014 | ADJ |

| ID | WBS | Activity | Type | Duration | Start | Finish | Predecessors | Total float | Free float | Calendar | Resources | Cost | RESP - Responsibility | STRT%COMP for CM EVM | FNSH%COMP for CM EVM | Advance Purchase Plan > 500K | CAM RESPONSIBLE | CR 10-009 | CR 11-026 | CR 12-054 | CR 11-VA2 | CR 13-014 | ReBaseline Actuals Adjustment | Original Activity ID Rebaseline | HALL D Related Milestones | EVMS Reporting Codes | CR 10-046 | CR 11-006 | CR 13-007 | BOE Procurement | CR 13-015 | Post Rebaseline | Obligated Prior to Rebaseline |
| --- | --- | --- | --- | --- | --- | --- | --- | --- | --- | --- | --- | --- | --- | --- | --- | --- | --- | --- | --- | --- | --- | --- | --- | --- | --- | --- | --- | --- | --- | --- | --- | --- | --- |
|  | 2 | **1.9.5.2.2.2 HALL D FORWARD CALORIMETER** |  |  | 2010-03-01 | 2013-10-31 |  |  |  |  |  |  |  |  |  |  |  |  |  |  |  |  |  |  |  |  |  |  |  |  |  |  |  |
| 195222010 |  | Prepare top level drawing documentation |  | 43d | 2010-03-01 | 2010-04-28 | 9-100M FS+97d | 148d | 0d |  |  |  | CHUDAKOV | 1 | 1 | APP | EUGENE C | 10-009 | 11-026 | 12-054F |  |  |  |  |  |  |  |  |  |  |  |  |  |
| 195222020 |  | Build Steel Tubes (fab) |  | 87d | 2010-03-01 | 2010-06-30 | 195222010 FS-43d, 195222015M FS-43d | 148d | 0d |  | PROCUREMENT<$50K 60 NO ESCALATION; PROCUREMENT>$50K 69 NO ESCALATION | 52,686 | CHUDAKOV | 1 | 1 | APP | EUGENE C | 10-009 | 11-026 | 12-054F |  |  |  |  |  |  |  |  |  |  |  |  |  |
| 195222025 |  | Build Steel Tubes (coat) |  | 108d | 2010-03-01 | 2010-07-30 | 195222020 FS-87d | 148d | 0d |  | PROCUREMENT>$50K 69 NO ESCALATION | 1,409 | CHUDAKOV | 1 | 1 | APP | EUGENE C | 10-009 | 11-026 | 12-054F |  |  |  |  |  |  |  |  |  |  |  |  |  |
| 195222030 |  | Build Tube Straps (procure material) |  | 87d | 2010-03-01 | 2010-06-30 | 195222025 FS-108d | 148d | 0d |  | PROCUREMENT>$50K 69 NO ESCALATION | 1,932 | CHUDAKOV | 1 | 1 | APP | EUGENE C | 10-009 | 11-026 | 12-054F |  |  |  |  |  |  |  |  |  |  |  |  |  |
| 195222035 |  | Build Tube Straps (shear) |  | 108d | 2010-03-01 | 2010-07-30 | 195222030 FS-87d | 148d | 0d |  | PROCUREMENT>$50K 69 NO ESCALATION | 2,239 | CHUDAKOV | 1 | 1 | APP | EUGENE C | 10-009 | 11-026 | 12-054F |  |  |  |  |  |  |  |  |  |  |  |  |  |
| 195222040 |  | Build Jack Plates |  | 108d | 2010-03-01 | 2010-07-30 | 195222035 FS-108d | 148d | 0d |  | PROCUREMENT>$50K 69 NO ESCALATION | 21,017 | CHUDAKOV | 1 | 1 | APP | EUGENE C | 10-009 | 11-026 | 12-054F |  |  |  |  |  |  |  |  |  |  |  |  |  |
| 195222045 |  | Build Face Plates |  | 65d | 2010-03-01 | 2010-05-28 | 195222040 FS-108d | 148d | 0d |  | PROCUREMENT>$50K 69 NO ESCALATION | 6,862 | CHUDAKOV | 1 | 1 | APP | EUGENE C | 10-009 | 11-026 | 12-054F |  |  |  |  |  |  |  |  |  |  |  |  |  |
| 195222050 |  | Pb Glass Preparation (weld straps) |  | 172d | 2010-03-01 | 2010-10-29 | 195222045 FS-65d | 148d | 0d |  | PROCUREMENT>$50K 69 NO ESCALATION | 13,830 | CHUDAKOV | 1 | 1 | APP | EUGENE C | 10-009 | 11-026 | 12-054F |  |  |  |  |  |  |  |  |  |  |  |  |  |
| 195222055 |  | Pb Glass Preparation (clean and wrap glass) |  | 209d | 2010-03-01 | 2010-12-30 | 195222050 FS-172d | 148d | 0d |  | PROCUREMENT>$50K 69 NO ESCALATION | 9,267 | CHUDAKOV | 1 | 1 | APP | EUGENE C | 10-009 | 11-026 | 12-054F |  |  |  |  |  |  |  |  |  |  |  |  |  |
| 195222060 |  | Pb Glass Preparation (attach sheild) |  | 248d | 2010-03-01 | 2011-02-28 | 195222055 FS-209d | 148d | 0d |  | PROCUREMENT>$50K 69 NO ESCALATION | 10,229 | CHUDAKOV | 1 | 1 | APP | EUGENE C | 10-009 | 11-026 | 12-054F |  |  |  |  |  |  |  |  |  |  |  |  |  |
| 195222065 |  | Pb Glass Preparation (prepare shippment) |  | 271d | 2010-03-01 | 2011-03-31 | 195222060 FS-248d | 148d | 0d |  | PROCUREMENT>$50K 69 NO ESCALATION | 3,120 | CHUDAKOV | 1 | 1 | APP | EUGENE C | 10-009 | 11-026 | 12-054F |  |  |  |  |  |  |  |  |  |  |  |  |  |
| 195222070 |  | Replacement pmts Testing |  | 5d | 2010-03-01 | 2010-03-05 | 195222065 FS-271d | 148d | 0d |  | PROCUREMENT>$50K 69 NO ESCALATION | 1,040 | CHUDAKOV | 1 | 1 | APP | EUGENE C | 10-009 | 11-026 | 12-054F |  |  |  |  |  |  |  |  |  |  |  |  |  |
| 195222075 |  | PMT Base Rods (procure) |  | 108d | 2010-03-01 | 2010-07-30 | 195222070 FS-5d | 148d | 0d |  | PROCUREMENT>$50K 69 NO ESCALATION | 22,847 | CHUDAKOV | 1 | 1 | APP | EUGENE C | 10-009 | 11-026 | 12-054F |  |  |  |  |  |  |  |  |  |  |  |  |  |
| 195222080 |  | PMT Base Housing (procure tubes) |  | 87d | 2010-03-01 | 2010-06-30 | 195222075 FS-108d | 148d | 0d |  | PROCUREMENT>$50K 69 NO ESCALATION | 9,581 | CHUDAKOV | 1 | 1 | APP | EUGENE C | 10-009 | 11-026 | 12-054F |  |  |  |  |  |  |  |  |  |  |  |  |  |
| 195222085 |  | PMT Base Housing (machine tubes) |  | 130d | 2010-03-01 | 2010-08-31 | 195222080 FS-87d | 148d | 0d |  | PROCUREMENT>$50K 69 NO ESCALATION | 3,864 | CHUDAKOV | 1 | 1 | APP | EUGENE C | 10-009 | 11-026 | 12-054F |  |  |  |  |  |  |  |  |  |  |  |  |  |
| 195222090 |  | PMT Base Housing (fabricate sockets) |  | 108d | 2010-03-01 | 2010-07-30 | 195222085 FS-130d | 148d | 0d |  | PROCUREMENT>$50K 69 NO ESCALATION | 16,240 | CHUDAKOV | 1 | 1 | APP | EUGENE C | 10-009 | 11-026 | 12-054F |  |  |  |  |  |  |  |  |  |  |  |  |  |
| 195222095 |  | PMT Base Housing (insert pins) |  | 130d | 2010-03-01 | 2010-08-31 | 195222090 FS-108d | 148d | 0d |  | PROCUREMENT>$50K 69 NO ESCALATION | 4,159 | CHUDAKOV | 1 | 1 | APP | EUGENE C | 10-009 | 11-026 | 12-054F |  |  |  |  |  |  |  |  |  |  |  |  |  |
| 195222100 |  | PMT Base Housing (package for assembly) |  | 130d | 2010-03-01 | 2010-08-31 | 195222095 FS-130d | 148d | 0d |  | PROCUREMENT>$50K 69 NO ESCALATION | 208 | CHUDAKOV | 1 | 1 | APP | EUGENE C | 10-009 | 11-026 | 12-054F |  |  |  |  |  |  |  |  |  |  |  |  |  |
| 195222105 |  | PMT Base Housing (back plate) |  | 108d | 2010-03-01 | 2010-07-30 | 195222100 FS-130d | 148d | 0d |  | PROCUREMENT>$50K 69 NO ESCALATION | 12,628 | CHUDAKOV | 1 | 1 | APP | EUGENE C | 10-009 | 11-026 | 12-054F |  |  |  |  |  |  |  |  |  |  |  |  |  |
| 195222110 |  | PMT Base Housing assembly |  | 23d | 2010-03-01 | 2010-03-31 | 195222105 FS-108d | 148d | 0d |  | PROCUREMENT>$50K 69 NO ESCALATION | 1,040 | CHUDAKOV | 1 | 1 | APP | EUGENE C | 10-009 | 11-026 | 12-054F |  |  |  |  |  |  |  |  |  |  |  |  |  |
| 195222115 |  | Prepare Base Circuit Fabrication Drawings |  | 108d | 2010-03-01 | 2010-07-30 | 195222110 FS-23d | 148d | 0d |  | PROCUREMENT>$50K 69 NO ESCALATION | 11,079 | CHUDAKOV | 1 | 1 | APP | EUGENE C | 10-009 | 11-026 | 12-054F |  |  |  |  |  |  |  |  |  |  |  |  |  |
| 195222125 |  | First Circuit Board Run PCB's (1/6 total) |  | 151d | 2010-03-01 | 2010-09-30 | 195222115 FS-108d, 195222120M FS-108d | 148d | 0d |  | PROCUREMENT>$50K 69 NO ESCALATION | 12,718 | CHUDAKOV | 1 | 1 | APP | EUGENE C | 10-009 | 11-026 | 12-054F |  |  |  |  |  |  |  |  |  |  |  |  |  |
| 195222130 |  | First Circuit Board Run Parts (1/6 total) |  | 130d | 2010-03-01 | 2010-08-31 | 195222125 FS-151d | 148d | 0d |  | PROCUREMENT>$50K 69 NO ESCALATION | 84,170 | CHUDAKOV | 1 | 1 | APP | EUGENE C | 10-009 | 11-026 | 12-054F |  |  |  |  |  |  |  |  |  |  |  |  |  |
| 195222135 |  | First Circuit Board Run Populate (1/6 total) |  | 151d | 2010-03-01 | 2010-09-30 | 195222130 FS-130d | 148d | 0d |  | PROCUREMENT>$50K 69 NO ESCALATION | 35,709 | CHUDAKOV | 1 | 1 | APP | EUGENE C | 10-009 | 11-026 | 12-054F |  |  |  |  |  |  |  |  |  |  |  |  |  |
| 195222140 |  | First Circuit Board Tester (1/6 total) |  | 130d | 2010-03-01 | 2010-08-31 | 195222135 FS-151d | 148d | 0d |  | PROCUREMENT>$50K 69 NO ESCALATION | 4,088 | CHUDAKOV | 1 | 1 | APP | EUGENE C | 10-009 | 11-026 | 12-054F |  |  |  |  |  |  |  |  |  |  |  |  |  |
| 195222145 |  | First Circuit Board Run Assembly (1/6 total) |  | 209d | 2010-03-01 | 2010-12-30 | 195222140 FS-130d | 148d | 0d |  | PROCUREMENT>$50K 69 NO ESCALATION | 13,226 | CHUDAKOV | 1 | 1 | APP | EUGENE C | 10-009 | 11-026 | 12-054F |  |  |  |  |  |  |  |  |  |  |  |  |  |
| 195222150 |  | First Circuit Board Run Testing (1/6 total) |  | 271d | 2010-03-01 | 2011-03-31 | 195222145 FS-209d | 148d | 0d |  | PROCUREMENT>$50K 69 NO ESCALATION | 44,316 | CHUDAKOV | 1 | 1 | APP | EUGENE C | 10-009 | 11-026 | 12-054F |  |  |  |  |  |  |  |  |  |  |  |  |  |
| 195222155 |  | Second Circuit Board Run PCBs (5/6 total) |  | 457d | 2010-03-01 | 2011-12-30 | 195222150 FS-271d | 148d | 0d |  | PROCUREMENT>$50K 69 NO ESCALATION | 33,283 | CHUDAKOV | 1 | 1 | APP | EUGENE C | 10-009 | 11-026 | 12-054F | 11-VA2 |  |  |  |  |  |  |  |  |  |  |  |  |
| 195222160 |  | Second Circuit Board Run Parts (5/6 total) |  | 378d | 2010-03-01 | 2011-08-31 | 195222155 FS-457d | 148d | 0d |  | PROCUREMENT>$50K 69 NO ESCALATION | 186,396 | CHUDAKOV | 1 | 1 | APP | EUGENE C | 10-009 | 11-026 | 12-054F | 11-VA2 |  |  |  |  |  |  |  |  |  |  |  |  |
| 195222165 |  | Second Circuit Board Run Populate (5/6 total) |  | 457d | 2010-03-01 | 2011-12-30 | 195222160 FS-378d | 148d | 0d |  | PROCUREMENT>$50K 69 NO ESCALATION | 156,132 | CHUDAKOV | 1 | 1 | APP | EUGENE C | 10-009 | 11-026 | 12-054F | 11-VA2 |  |  |  |  |  |  |  |  |  |  |  |  |
| 195222170 |  | Second Circuit Board Run Assemble and Test (5/6 total) |  | 519d | 2010-03-01 | 2012-03-30 | 195222165 FS-457d | 148d | 0d |  | PROCUREMENT>$50K 69 NO ESCALATION | 64,990 | CHUDAKOV | 1 | 1 | APP | EUGENE C | 10-009 | 11-026 | 12-054F | 11-VA2 |  |  |  |  |  |  |  |  |  |  |  |  |
| 195222175 |  | Prepare Pb Glass Drawings |  | 65d | 2010-03-01 | 2010-05-28 | 195222170 FS-519d | 148d | 0d |  |  |  | CHUDAKOV | 1 | 1 | APP | EUGENE C | 10-009 | 11-026 | 12-054F |  |  |  |  |  |  |  |  |  |  |  |  |  |
| 195222180M |  | Jlab Reveiw and Approval of Support Drawings | milestone | 0d | 2010-03-01 | 2010-03-01 | 195222175 SS | 213d | 65d |  |  |  | CHUDAKOV | 1 | 1 | APP | EUGENE C | 10-009 | 11-026 | 12-054F |  |  |  |  |  |  |  |  |  |  |  |  |  |
| 195222185 |  | Procure Materials for PB Glass Support |  | 151d | 2010-03-01 | 2010-09-30 | 195222180M FS-65d, 195222175 FS-65d | 148d | 0d |  | PROCUREMENT>$50K 69 NO ESCALATION | 11,882 | CHUDAKOV | 1 | 1 | APP | EUGENE C | 10-009 | 11-026 | 12-054F |  |  |  |  |  |  |  |  |  |  |  |  |  |
| 195222190 |  | Machine Componants for PB Glass Support |  | 292d | 2010-03-01 | 2011-04-29 | 195222185 FF, 195222185 FS-151d | 148d | 0d |  | PROCUREMENT>$50K 69 NO ESCALATION | 2,778 | CHUDAKOV | 1 | 1 | APP | EUGENE C | 10-009 | 11-026 | 12-054F |  |  |  |  |  |  |  |  |  |  |  |  |  |
| 195222195 |  | Assemble Pb Glass Support Structure |  | 313d | 2010-03-01 | 2011-05-31 | 195222190 FS-292d | 148d | 0d |  | PROCUREMENT>$50K 69 NO ESCALATION | 14,473 | CHUDAKOV | 1 | 1 | APP | EUGENE C | 10-009 | 11-026 | 12-054F |  |  |  |  |  |  |  |  |  |  |  |  |  |
| 195222200 |  | Light Guide Material Procurement |  | 108d | 2010-03-01 | 2010-07-30 | 195222195 FS-313d | 148d | 0d |  | PROCUREMENT>$50K 69 NO ESCALATION | 9,062 | CHUDAKOV | 1 | 1 | APP | EUGENE C | 10-009 | 11-026 | 12-054F |  |  |  |  |  |  |  |  |  |  |  |  |  |
| 195222205 |  | Glue and Wrap Light Guides |  | 497d | 2010-03-01 | 2012-02-29 | 195222200 FS-108d | 148d | 0d |  | PROCUREMENT>$50K 69 NO ESCALATION | 19,254 | CHUDAKOV | 1 | 1 | APP | EUGENE C | 10-009 | 11-026 | 12-054F |  |  |  |  |  |  |  |  |  |  |  |  |  |
| 195222210 |  | Slow Control (procure CAN/ethernet devices) |  | 562d | 2010-03-01 | 2012-05-31 | 195222205 FS-497d | 148d | 0d |  | PROCUREMENT>$50K 69 NO ESCALATION | 6,933 | CHUDAKOV | 1 | 1 | APP | EUGENE C | 10-009 | 11-026 | 12-054F |  |  |  |  |  |  |  |  |  |  |  |  |  |
| 195222215 |  | Slow Control (procure cables) |  | 562d | 2010-03-01 | 2012-05-31 | 195222210 FS-562d | 148d | 0d |  | PROCUREMENT>$50K 69 NO ESCALATION | 5,185 | CHUDAKOV | 1 | 1 | APP | EUGENE C | 10-009 | 11-026 | 12-054F |  |  |  |  |  |  |  |  |  |  |  |  |  |
| 195222220 |  | Slow Control (assemble and test slow control) |  | 582d | 2010-03-01 | 2012-06-29 | 195222215 FS-562d | 148d | 0d |  | PROCUREMENT>$50K 69 NO ESCALATION | 3,120 | CHUDAKOV | 1 | 1 | APP | EUGENE C | 10-009 | 11-026 | 12-054F |  |  |  |  |  |  |  |  |  |  |  |  |  |
| 195222225 |  | Final PMT Test (test fixture) |  | 108d | 2010-03-01 | 2010-07-30 | 195222220 FS-582d | 148d | 0d |  | PROCUREMENT>$50K 69 NO ESCALATION | 2,722 | CHUDAKOV | 1 | 1 | APP | EUGENE C | 10-009 | 11-026 | 12-054F |  |  |  |  |  |  |  |  |  |  |  |  |  |
| 195222230 |  | Final PMT Test (test PMT and bases) |  | 540d | 2010-03-01 | 2012-04-30 | 195222225 FS-108d | 148d | 0d |  | PROCUREMENT>$50K 69 NO ESCALATION | 6,239 | CHUDAKOV | 1 | 1 | APP | EUGENE C | 10-009 | 11-026 | 12-054F |  |  |  |  |  |  |  |  |  |  |  |  |  |
| 195222235 |  | Final PMT Test (package and shipment) |  | 540d | 2010-03-01 | 2012-04-30 | 195222230 FS-540d | 148d | 0d |  | PROCUREMENT>$50K 69 NO ESCALATION | 1,560 | CHUDAKOV | 1 | 1 | APP | EUGENE C | 10-009 | 11-026 | 12-054F |  |  |  |  |  |  |  |  |  |  |  |  |  |
| 195222240 |  | Fabricate Optical Cookies (material) |  | 562d | 2010-03-01 | 2012-05-31 | 195222235 FS-540d | 148d | 0d |  | PROCUREMENT>$50K 69 NO ESCALATION | 8,331 | CHUDAKOV | 1 | 1 | APP | EUGENE C | 10-009 | 11-026 | 12-054F |  |  |  |  |  |  |  |  |  |  |  |  |  |
| 195222245 |  | Fabricate Optical Cookies (cut cookies) |  | 582d | 2010-03-01 | 2012-06-29 | 195222240 FS-562d | 148d | 0d |  | PROCUREMENT>$50K 69 NO ESCALATION | 1,757 | CHUDAKOV | 1 | 1 | APP | EUGENE C | 10-009 | 11-026 | 12-054F |  |  |  |  |  |  |  |  |  |  |  |  |  |
| 195222250 |  | Fabricate Optical Cookies (Package for shipment) |  | 582d | 2010-03-01 | 2012-06-29 | 195222245 FS-582d | 148d | 0d |  | PROCUREMENT>$50K 69 NO ESCALATION | 520 | CHUDAKOV | 1 | 1 | APP | EUGENE C | 10-009 | 11-026 | 12-054F |  |  |  |  |  |  |  |  |  |  |  |  |  |
| 195222255 |  | Cable Refurbishment (locate and acquire cables) |  | 209d | 2010-03-01 | 2010-12-30 | 195222250 FS-582d | 148d | 0d |  | PROCUREMENT>$50K 69 NO ESCALATION | 4,902 | CHUDAKOV | 1 | 1 | APP | EUGENE C | 10-009 | 11-026 | 12-054F |  |  |  |  |  |  |  |  |  |  |  |  |  |
| 195222260 |  | Cable Refurbishment (procure connectors) |  | 209d | 2010-03-01 | 2010-12-30 | 195222255 FS-209d | 148d | 0d |  | PROCUREMENT>$50K 69 NO ESCALATION | 13,749 | CHUDAKOV | 1 | 1 | APP | EUGENE C | 10-009 | 11-026 | 12-054F |  |  |  |  |  |  |  |  |  |  |  |  |  |
| 195222265 |  | Cable Refurbishment (install connectors) |  | 229d | 2010-03-01 | 2011-01-31 | 195222260 FS-209d | 148d | 0d |  | PROCUREMENT>$50K 69 NO ESCALATION | 1,560 | CHUDAKOV | 1 | 1 | APP | EUGENE C | 10-009 | 11-026 | 12-054F |  |  |  |  |  |  |  |  |  |  |  |  |  |
| 195222270 |  | Cable Refurbishment (package for shipment) |  | 229d | 2010-03-01 | 2011-01-31 | 195222265 FS-229d | 148d | 0d |  | PROCUREMENT>$50K 69 NO ESCALATION | 520 | CHUDAKOV | 1 | 1 | APP | EUGENE C | 10-009 | 11-026 | 12-054F |  |  |  |  |  |  |  |  |  |  |  |  |  |
| 195222275 |  | Procure Magnetic Sheilds |  | 582d | 2010-03-01 | 2012-06-29 | 195222270 FS-229d | 148d | 0d |  | PROCUREMENT>$50K 69 NO ESCALATION | 49,663 | CHUDAKOV | 1 | 1 | APP | EUGENE C | 10-009 | 11-026 | 12-054F |  |  |  |  |  |  |  |  |  |  |  |  |  |
| 195222280 |  | Procure Shipping Materials |  | 130d | 2010-03-01 | 2010-08-31 | 195222275 FS-582d | 148d | 0d |  | PROCUREMENT>$50K 69 NO ESCALATION | 13,396 | CHUDAKOV | 1 | 1 | APP | EUGENE C | 10-009 | 11-026 | 12-054F |  |  |  |  |  |  |  |  |  |  |  |  |  |
| 195222285 |  | Shipping to Jlab |  | 582d | 2010-03-01 | 2012-06-29 | 195222280 FS-130d | 148d | 124d |  | PROCUREMENT>$50K 69 NO ESCALATION | 9,189 | CHUDAKOV | 1 | 1 | APP | EUGENE C | 10-009 | 11-026 | 12-054F |  |  |  |  |  |  |  |  |  |  |  |  |  |
| 195222015M |  | Readiness Review | milestone | 0d | 2010-04-29 | 2010-04-29 | 195222010 SS, 195222010 | 148d | 0d |  |  |  | CHUDAKOV | 1 | 1 | APP | EUGENE C | 10-009 | 11-026 | 12-054F |  |  |  |  |  |  |  |  |  |  |  |  |  |
| 195222120M |  | Jlab Reveiw and Approval of Base Circuit Design | milestone | 0d | 2010-07-21 | 2010-07-21 | 195222115 FS-8d | 156d | 8d |  |  |  | CHUDAKOV | 1 | 1 | APP | EUGENE C | 10-009 | 11-026 | 12-054F |  |  |  |  |  |  |  |  |  |  |  |  |  |
| 195222290 |  | Re-Baseline Actuals Adjustment |  | 1d | 2013-08-30 | 2013-08-30 | 9-130M FS+227d | 20d |  |  | PROCUREMENT>$50K 69 NO ESCALATION | -8,558.26 | CHUDAKOV | 1 | 1 |  | EUGENE C |  |  |  |  | 13-014 | ADJ |  |  |  |  |  |  |  |  |  |  |
| 295222000 |  | Indiana Contract Completion |  | 43d | 2013-09-03 | 2013-10-31 | 9-130M FS+228d | 224d |  | 8/5 M-F w/JLAB Holidays ReBaseline | PROCUREMENT<$50K 60 NO ESCALATION; PROCUREMENT>$50K 69 NO ESCALATION | 8,558.26 | CHUDAKOV | 1 | 1 |  | EUGENE C |  | 11-026 | 12-054F |  |  |  | 295212260 | D | D | 10-046 | 11-006 | 13-007F | OB | 13-015 | PR | OB |

| ID | WBS | Activity | Type | Duration | Start | Finish | Predecessors | Total float | Free float | Calendar | Resources | Cost | RESP - Responsibility | STRT%COMP for CM EVM | FNSH%COMP for CM EVM | Advance Purchase Plan > 500K | CAM RESPONSIBLE | 12 GEV MAJOR PROCUREMENT CATAGORY | CR 11-016 | CR 11-VA3 | CR 12-015 | CR 13-014 | ReBaseline Actuals Adjustment | HALL D Related Milestones | CR 10-001 | CR 11-006 | CR 11-026 | CR 12-054 | CR 11-001 | Original Activity ID Rebaseline | EVMS Reporting Codes | CR 10-046 | CR 13-007 | BOE Procurement | CR 13-015 | Post Rebaseline | Obligated Prior to Rebaseline |
| --- | --- | --- | --- | --- | --- | --- | --- | --- | --- | --- | --- | --- | --- | --- | --- | --- | --- | --- | --- | --- | --- | --- | --- | --- | --- | --- | --- | --- | --- | --- | --- | --- | --- | --- | --- | --- | --- |
|  | 6 | **1.9.6 12 GeV ACCEL BUILDINGS** |  |  | 2010-12-01 | 2013-08-30 |  |  |  |  |  |  |  |  |  |  |  |  |  |  |  |  |  |  |  |  |  |  |  |  |  |  |  |  |  |  |  |
|  | 1 | **1.9.6.1 12 GeV N&S ACCESS LCW UPGRADES** |  |  | 2010-12-01 | 2013-08-30 |  |  |  |  |  |  |  |  |  |  |  |  |  |  |  |  |  |  |  |  |  |  |  |  |  |  |  |  |  |  |  |
| 1961000 |  | N&S Access LCW Upgrades Constrctn Contract Progress December 2010 |  | 17d | 2010-12-01 | 2010-12-30 | 9-110M FS+41d | 475d | 0d |  |  |  | WHITLATCH C | 1 | 1 | APP | REBECCA Y | 6112 | 11-016 | 11-VA3 | 12-015 |  |  |  |  |  |  |  |  |  |  |  |  |  |  |  |  |
| 1961000a |  | N&S Access LCW Upgrades Constrctn Contract Progress January 2011 |  | 37d | 2010-12-01 | 2011-01-31 | 1961000 FS-17d | 475d | 0d |  |  |  | WHITLATCH C | 1 | 1 | APP | REBECCA Y | 6112 | 11-016 | 11-VA3 | 12-015 |  |  |  |  |  |  |  |  |  |  |  |  |  |  |  |  |
| 1961000b |  | N&S Access LCW Upgrades Constrctn Contract Progress February 2011 |  | 56d | 2010-12-01 | 2011-02-28 | 1961000a FS-37d | 475d | 0d |  |  |  | WHITLATCH C | 1 | 1 | APP | REBECCA Y | 6112 | 11-016 | 11-VA3 | 12-015 |  |  |  |  |  |  |  |  |  |  |  |  |  |  |  |  |
| 1961000c |  | N&S Access LCW Upgrades Constrctn Contract Progress March 2011 |  | 79d | 2010-12-01 | 2011-03-31 | 1961000b FS-56d | 475d | 0d |  | PROCUREMENT<$50K 60 NO ESCALATION; PROCUREMENT>$50K 69 NO ESCALATION | 184,600 | WHITLATCH C | 1 | 1 | APP | REBECCA Y | 6112 | 11-016 | 11-VA3 | 12-015 |  |  |  |  |  |  |  |  |  |  |  |  |  |  |  |  |
| 1961000d |  | N&S Access LCW Upgrades Constrctn Contract Progress April 2011 |  | 100d | 2010-12-01 | 2011-04-29 | 1961000c FS-79d | 475d | 0d |  | PROCUREMENT>$50K 69 NO ESCALATION | 844,600 | WHITLATCH C | 1 | 1 | APP | REBECCA Y | 6112 | 11-016 | 11-VA3 | 12-015 |  |  |  |  |  |  |  |  |  |  |  |  |  |  |  |  |
| 1961000f |  | N&S Access LCW Upgrades Constrctn Contract Progress May 2011 |  | 121d | 2010-12-01 | 2011-05-31 | 1961000d FS-100d | 475d | 0d |  | PROCUREMENT>$50K 69 NO ESCALATION | 1,106,800 | WHITLATCH C | 1 | 1 | APP | REBECCA Y | 6112 | 11-016 | 11-VA3 | 12-015 |  |  |  |  |  |  |  |  |  |  |  |  |  |  |  |  |
| 1961000g |  | N&S Access LCW Upgrades Constrctn Contract Progress June 2011 |  | 143d | 2010-12-01 | 2011-06-30 | 1961000f FS-121d | 475d | 0d |  | PROCUREMENT>$50K 69 NO ESCALATION | 420,200 | WHITLATCH C | 1 | 1 | APP | REBECCA Y | 6112 | 11-016 | 11-VA3 | 12-015 |  |  |  |  |  |  |  |  |  |  |  |  |  |  |  |  |
| 1961000h |  | N&S Access LCW Upgrades Constrctn Contract Progress July 2011 |  | 163d | 2010-12-01 | 2011-07-29 | 1961000g FS-143d | 475d | 0d |  | PROCUREMENT>$50K 69 NO ESCALATION | 227,100 | WHITLATCH C | 1 | 1 | APP | REBECCA Y | 6112 | 11-016 | 11-VA3 | 12-015 |  |  |  |  |  |  |  |  |  |  |  |  |  |  |  |  |
| 1961000j |  | N&S Access LCW Upgrades Constrctn Contract Progress August 2011 |  | 186d | 2010-12-01 | 2011-08-31 | 1961000h FS-163d | 475d | 0d |  | PROCUREMENT>$50K 69 NO ESCALATION | 239,000 | WHITLATCH C | 1 | 1 | APP | REBECCA Y | 6112 | 11-016 | 11-VA3 | 12-015 |  |  |  |  |  |  |  |  |  |  |  |  |  |  |  |  |
| 1961000k |  | N&S Access LCW Upgrades Constrctn Contract Progress September 2011 |  | 207d | 2010-12-01 | 2011-09-30 | 1961000j FS-186d | 475d | 0d |  | PROCUREMENT>$50K 69 NO ESCALATION | 205,700 | WHITLATCH C | 1 | 1 | APP | REBECCA Y | 6112 | 11-016 | 11-VA3 | 12-015 |  |  |  |  |  |  |  |  |  |  |  |  |  |  |  |  |
| 1961000n |  | N&S Access LCW Upgrades Constrctn Contract Progress October 2011 |  | 228d | 2010-12-01 | 2011-10-31 | 1961000k FS-207d | 475d | 0d |  | PROCUREMENT>$50K 69 NO ESCALATION | 58,000 | WHITLATCH C | 1 | 1 | APP | REBECCA Y | 6112 | 11-016 | 11-VA3 | 12-015 |  |  |  |  |  |  |  |  |  |  |  |  |  |  |  |  |
| 1961005 |  | N&S Access LCW Upgrades Contract Modifications |  | 228d | 2010-12-01 | 2011-10-31 | 9-110M FS+41d | 475d | 0d |  | PROCUREMENT>$50K 69 NO ESCALATION | 164,000 | WHITLATCH C | 1 | 1 | APP | REBECCA Y | 6112 | 11-016 | 11-VA3 | 12-015 |  |  |  |  |  |  |  |  |  |  |  |  |  |  |  |  |
| 1961010 |  | Re-Baseline Actuals Adjustment |  | 1d | 2013-08-30 | 2013-08-30 | 9-130M FS+227d | 20d |  |  | PROCUREMENT>$50K 69 NO ESCALATION | -25,739.57 | WHITLATCH C | 1 | 1 |  | REBECCA Y |  |  |  |  | 13-014 | ADJ |  |  |  |  |  |  |  |  |  |  |  |  |  |  |
|  | 7 | **1.9.7 12 Gev Infastructure** |  |  | 2010-07-01 | 2013-10-31 |  |  |  |  |  |  |  |  |  |  |  |  |  |  |  |  |  |  |  |  |  |  |  |  |  |  |  |  |  |  |  |
|  | 1 | **1.9.7.1 12 Gev Misc Infastructure** |  |  | 2010-07-01 | 2013-10-31 |  |  |  |  |  |  |  |  |  |  |  |  |  |  |  |  |  |  |  |  |  |  |  |  |  |  |  |  |  |  |  |
| 197111005 |  | Procure 2000 Sq. Ft. CLASS 10,000 Clean Room |  | 85d | 2010-07-01 | 2010-10-29 | 9-100M FS+184d | 126.5d | 0d |  | PROCUREMENT<$50K 60 NO ESCALATION FY11; PROCUREMENT>$50K 69 NO ESCALATION FY11 | 250,000 | CHUDAKOV | 1 | 1 |  | EUGENE C |  |  |  |  |  |  | D | 10-1VA | 11-006 | 11-026 | 12-054F |  |  |  |  |  |  |  |  |  |
| 197111010 |  | Procure HVAC Unit |  | 43d | 2010-07-01 | 2010-08-31 | 9-100M FS+184d | 148.5d | 0d |  | PROCUREMENT<$50K 60; PROCUREMENT>$50K 69 | 90,000 | CHUDAKOV | 1 | 1 |  | EUGENE C |  |  |  |  |  |  | D | 10-1VA | 11-006 | 11-026 | 12-054F |  |  |  |  |  |  |  |  |  |
| 197111001M |  | Space rented for Chamber Work | milestone | 0d | 2010-08-02 | 2010-08-02 | 9-100M FS+205d | 126.5d | 0d |  |  |  | CHUDAKOV | 1 | 1 |  | EUGENE C |  |  |  |  |  |  | D | 10-1VA | 11-006 | 11-026 | 12-054F |  |  |  |  |  |  |  |  |  |
| 197111020 |  | Modify Building Electrical Distribution FY10 |  | 43d | 2010-08-02 | 2010-09-30 | 197111001M | 126.5d | 0d |  | ELEC TECH [506.06 h] | 20,976.19 | CHUDAKOV | 1 | 1 |  | EUGENE C |  |  |  |  |  |  | D | 10-1VA | 11-006 | 11-026 | 12-054F | 11-001 |  |  |  |  |  |  |  |  |
| 197111015 |  | Install HVAC Unit |  | 20d | 2010-09-01 | 2010-09-29 | 197111010 | 148.5d | 22d |  | MECH TECH [251.6 h] | 10,501.78 | CHUDAKOV | 1 | 1 |  | EUGENE C |  |  |  |  |  |  | D | 10-1VA | 11-006 | 11-026 | 12-054F |  |  |  |  |  |  |  |  |  |
| 197111020a |  | Modify Building Electrical Distribution FY11 |  | 21d | 2010-10-01 | 2010-10-29 | 197111020 | 126.5d | 0d |  | ELEC TECH [247.14 h] | 10,570.18 | CHUDAKOV | 1 | 1 |  | EUGENE C |  |  |  |  |  |  | D | 10-1VA | 11-006 | 11-026 | 12-054F | 11-001 |  |  |  |  |  |  |  |  |
| 197111060 |  | Blue Crab Lease October-2010 |  | 21d | 2010-10-01 | 2010-10-29 | 9-110M | 6d | 0d |  | PROCUREMENT<$50K 60 NO ESCALATION; PROCUREMENT>$50K 69 NO ESCALATION | 34,702.89 | CHUDAKOV | 1 | 1 |  | EUGENE C |  |  |  |  |  |  | D |  |  |  |  | 11-1VA |  |  |  |  |  |  |  |  |
| 197111065 |  | Blue Crab Lease |  | 717d | 2010-10-01 | 2013-08-22 | 197111060 FS-21d | 6d |  |  | PROCUREMENT<$50K 60 NO ESCALATION; PROCUREMENT>$50K 69 NO ESCALATION | 235,254.99 | CHUDAKOV | 1 | 1 |  | EUGENE C |  |  |  |  |  |  | D |  |  |  |  | 11-1VA |  |  |  |  |  |  |  |  |
| 197111080 |  | Blue Crab Utilities October-2010 |  | 21d | 2010-10-01 | 2010-10-29 | 9-110M | 6d | 0d |  | PROCUREMENT>$50K 69 NO ESCALATION | 2,051.51 | CHUDAKOV | 1 | 1 |  | EUGENE C |  |  |  |  |  |  | D |  |  |  |  | 11-1VA |  |  |  |  |  |  |  |  |
| 197111085 |  | Blue Crab Utilities |  | 717d | 2010-10-01 | 2013-08-22 | 197111080 FS-21d | 6d |  |  | PROCUREMENT>$50K 69 NO ESCALATION | 57,948.49 | CHUDAKOV | 1 | 1 |  | EUGENE C |  |  |  |  |  |  | D |  |  |  |  | 11-1VA |  |  |  |  |  |  |  |  |
| 197111100 |  | Blue Crab Fork Lift-2010 |  | 21d | 2010-10-01 | 2010-10-29 | 9-110M | 355d | 0d |  | PROCUREMENT>$50K 69 NO ESCALATION | 4,685.2 | CHUDAKOV | 1 | 1 |  | EUGENE C |  |  |  |  |  |  | D |  |  |  |  | 11-1VA |  |  |  |  |  |  |  |  |
| 197111105 |  | Blue Crab Fork Lift-FY11/12 |  | 368d | 2010-10-01 | 2012-03-30 | 197111100 FS-21d | 355d |  |  | PROCUREMENT>$50K 69 NO ESCALATION | 27,378 | CHUDAKOV | 1 | 1 |  | EUGENE C |  |  |  |  |  |  | D |  |  |  |  | 11-1VA |  |  |  |  |  |  |  |  |
| 197111110 |  | Blue Crab Shelving |  | 21d | 2010-10-01 | 2010-10-29 | 9-110M | 702d |  |  | PROCUREMENT>$50K 69 NO ESCALATION | 36,648.53 | CHUDAKOV | 1 | 1 |  | EUGENE C |  |  |  |  |  |  | D |  |  |  |  | 11-1VA |  |  |  |  |  |  |  |  |
| 197111115 |  | Blue Crab Janitorial October-2010 |  | 21d | 2010-10-01 | 2010-10-29 | 9-110M | 64d | 0d |  | SUPPLIES & MATERIALS | 240.36 | CHUDAKOV | 1 | 1 |  | EUGENE C |  |  |  |  |  |  | D |  |  |  |  | 11-1VA |  |  |  |  |  |  |  |  |
| 197111030M |  | Space Ready | milestone | 0d | 2010-11-01 | 2010-11-01 | 197111015, 197111020a, 197111005 | 126.5d | 17d |  |  |  | CHUDAKOV | 1 | 1 |  | EUGENE C |  |  |  |  |  |  | D | 10-1VA | 11-006 | 11-026 | 12-054F |  |  |  |  |  |  |  |  |  |
| 197111045 |  | Blue Crab Phone Lines Upfront Costs |  | 20d | 2010-11-01 | 2010-11-30 | 9-110M FS+21d | 6d | 0d |  | SUPPLIES & MATERIALS | 1,015 | CHUDAKOV | 1 | 1 |  | EUGENE C |  |  |  |  |  |  | D |  |  |  |  | 11-1VA |  |  |  |  |  |  |  |  |
| 197111055 |  | Blue Crab Phone Lines FY11 |  | 248d | 2010-11-01 | 2011-10-31 | 197111045 FS-20d | 6d | 0d |  | PROCUREMENT<$50K 60 NO ESCALATION | 1,836 | CHUDAKOV | 1 | 1 |  | EUGENE C |  |  |  |  |  |  | D |  |  |  |  | 11-1VA |  |  |  |  |  |  |  |  |
| 197111135 |  | Blue Crab Misc. Supplies FY11 |  | 207d | 2010-12-01 | 2011-09-30 | 9-110M FS+41d | 6d | 0d |  | SUPPLIES & MATERIALS | 77,399.52 | CHUDAKOV | 1 | 1 |  | EUGENE C |  |  |  |  |  |  | D |  |  |  |  | 11-1VA |  |  |  |  |  |  |  |  |
| 197111120 |  | Blue Crab Janitorial FY11 |  | 189d | 2011-01-04 | 2011-09-30 | 197111115 FS+38d | 64d | 0d |  | SUPPLIES & MATERIALS | 1,365 | CHUDAKOV | 1 | 1 |  | EUGENE C |  |  |  |  |  |  | D |  |  |  |  | 11-1VA |  |  |  |  |  |  |  |  |
| 197111125 |  | Blue Crab Janitorial FY12 |  | 247d | 2011-10-03 | 2012-09-28 | 197111120 | 64d | 0d |  | SUPPLIES & MATERIALS | 1,878.06 | CHUDAKOV | 1 | 1 |  | EUGENE C |  |  |  |  |  |  | D |  |  |  |  | 11-1VA |  |  |  |  |  |  |  |  |
| 197111140 |  | Blue Crab Misc. Supplies FY12 |  | 247d | 2011-10-03 | 2012-09-28 | 197111135 | 6d | 0d |  | SUPPLIES & MATERIALS | 51,595 | CHUDAKOV | 1 | 1 |  | EUGENE C |  |  |  |  |  |  | D |  |  |  |  | 11-1VA |  |  |  |  |  |  |  |  |
| 197111058 |  | Blue Crab Phone Lines FY12 |  | 226d | 2011-11-01 | 2012-09-28 | 197111055 | 6d | 0d |  | SUPPLIES & MATERIALS | 1,736.69 | CHUDAKOV | 1 | 1 |  | EUGENE C |  |  |  |  |  |  | D |  |  |  |  | 11-1VA |  |  |  |  |  |  |  |  |
| 197111059 |  | Blue Crab Phone Lines FY13 |  | 222d | 2012-10-01 | 2013-08-22 | 197111058 | 6d |  |  | SUPPLIES & MATERIALS | 1,792.09 | CHUDAKOV | 1 | 1 |  | EUGENE C |  |  |  |  |  |  | D |  |  |  |  | 11-1VA |  |  |  |  |  |  |  |  |
| 197111130 |  | Blue Crab Janitorial FY13 |  | 164d | 2012-10-01 | 2013-05-31 | 197111125 | 64d |  |  | SUPPLIES & MATERIALS | 1,304.4 | CHUDAKOV | 1 | 1 |  | EUGENE C |  |  |  |  |  |  | D |  |  |  |  | 11-1VA |  |  |  |  |  |  |  |  |
| 197111145 |  | Blue Crab Misc. Supplies FY13 |  | 222d | 2012-10-01 | 2013-08-22 | 197111140 | 6d |  |  | SUPPLIES & MATERIALS | 26,620.44 | CHUDAKOV | 1 | 1 |  | EUGENE C |  |  |  |  |  |  | D |  |  |  |  | 11-1VA |  |  |  |  |  |  |  |  |
| 197111150 |  | Re-Baseline Actuals Adjustment |  | 1d | 2013-08-30 | 2013-08-30 | 9-130M FS+227d | 20d |  |  | PROCUREMENT>$50K 69 NO ESCALATION | -19,991.49 | CHUDAKOV | 1 | 1 |  | EUGENE C |  |  |  |  | 13-014 | ADJ |  |  |  |  |  |  |  |  |  |  |  |  |  |  |
| 2971000 |  | Blue Crab Cleanroom Completion |  | 43d | 2013-09-03 | 2013-10-31 | 295212255 FS-43d | 224d |  | 8/5 M-F w/JLAB Holidays ReBaseline | PROCUREMENT<$50K 60 NO ESCALATION; PROCUREMENT>$50K 69 NO ESCALATION | 29,009.92 | CHUDAKOV | 1 | 1 |  | EUGENE C |  |  |  |  |  |  | D |  | 11-006 | 11-026 | 12-054F |  | 295212260 | D | 10-046 | 13-007F | OB | 13-015 | PR | OB |

| ID | WBS | Activity | Duration | Start | Finish | Predecessors | Total float | Resources | Cost | RESP - Responsibility | STRT%COMP for CM EVM | FNSH%COMP for CM EVM | Advance Purchase Plan > 500K | CAM RESPONSIBLE | CR 10-011 | CR 10-014 | CR 08-016 | CR 09-012 | CR 09-022 | CR 10-069 | CR 11-026 | CR 11-046 |
| --- | --- | --- | --- | --- | --- | --- | --- | --- | --- | --- | --- | --- | --- | --- | --- | --- | --- | --- | --- | --- | --- | --- |
|  | 10 | **1.10 NON DOE SCOPE** |  | 2009-12-01 | 2013-06-21 |  |  |  |  |  |  |  |  |  |  |  |  |  |  |  |  |  |
|  | 2 | **1.10.2 HALL B NSF-FUNDED DETECTORS** |  | 2009-12-01 | 2010-09-30 |  |  |  |  |  |  |  |  |  |  |  |  |  |  |  |  |  |
|  | 2 | **1.10.2.2 HALL B NSF-FUNDED DETECTORS-CALORIMETERS** |  | 2009-12-01 | 2010-09-30 |  |  |  |  |  |  |  |  |  |  |  |  |  |  |  |  |  |
|  | 3 | **1.10.2.2.3 NSF-MRI ACTIVITIES FOR CLAS 12 PRESHOWER CALORIMETER** |  | 2009-12-01 | 2010-09-30 |  |  |  |  |  |  |  |  |  |  |  |  |  |  |  |  |  |
|  | 1 | **1.10.2.2.3.1 WAVELENGTH SHIFTING FIBERS** |  | 2009-12-01 | 2010-09-30 |  |  |  |  |  |  |  |  |  |  |  |  |  |  |  |  |  |
| 1102231000 |  | Placeholder NSF Wavelength Shifting Fiber Procurement | 207d | 2009-12-01 | 2010-09-30 | 9-100M FS+41d | 0d | PROCUREMENT>$50K 69 | 120,000 | ELOUADRHIRI L | 1 | 1 | APP | LATIFA E | 10-011 | 10-014 |  |  |  |  |  |  |
|  | 2 | **1.10.2.2.3.2 PMT SYSTEM** |  | 2009-12-01 | 2010-09-30 |  |  |  |  |  |  |  |  |  |  |  |  |  |  |  |  |  |
|  | 1 | **1.10.2.2.3.2.1 PHOTOMULTIPLIER TUBES** |  | 2009-12-01 | 2010-09-30 |  |  |  |  |  |  |  |  |  |  |  |  |  |  |  |  |  |
| 11022321000 |  | Placeholder NSF Photomultiplier Tube Procurement | 207d | 2009-12-01 | 2010-09-30 | 9-100M FS+41d | 0d | PROCUREMENT>$50K 69 | 218,000 | ELOUADRHIRI L | 1 | 1 | APP | LATIFA E | 10-011 | 10-014 |  |  |  |  |  |  |
|  | 2 | **1.10.2.2.3.2.2 MU-METAL SHIELDS** |  | 2009-12-01 | 2010-09-30 |  |  |  |  |  |  |  |  |  |  |  |  |  |  |  |  |  |
| 11022322000 |  | Placeholder NSF Mu-Metal Shield Procurement | 207d | 2009-12-01 | 2010-09-30 | 9-100M FS+41d | 0d | PROCUREMENT>$50K 69 | 18,000 | ELOUADRHIRI L | 1 | 1 | APP | LATIFA E | 10-011 | 10-014 |  |  |  |  |  |  |
|  | 3 | **1.10.2.2.3.2.3 HIGH VOLTAGE CABLES** |  | 2009-12-01 | 2010-09-30 |  |  |  |  |  |  |  |  |  |  |  |  |  |  |  |  |  |
| 11022323000 |  | Placeholder NSF High Voltage Cable Procurement | 207d | 2009-12-01 | 2010-09-30 | 9-100M FS+41d | 0d | PROCUREMENT>$50K 69 | 59,000 | ELOUADRHIRI L | 1 | 1 | APP | LATIFA E | 10-011 | 10-014 |  |  |  |  |  |  |
|  | 4 | **1.10.2.2.3.2.4 SIGNAL SPLITTERS** |  | 2009-12-01 | 2010-09-30 |  |  |  |  |  |  |  |  |  |  |  |  |  |  |  |  |  |
| 11022324000 |  | Placeholder NSF Signal Splitters Procurement | 207d | 2009-12-01 | 2010-09-30 | 9-100M FS+41d | 0d | PROCUREMENT>$50K 69 | 27,000 | ELOUADRHIRI L | 1 | 1 | APP | LATIFA E | 10-011 | 10-014 |  |  |  |  |  |  |
|  | 5 | **1.10.2.2.3.2.5 ELECTRONICS CABLES** |  | 2009-12-01 | 2010-09-30 |  |  |  |  |  |  |  |  |  |  |  |  |  |  |  |  |  |
| 11022325000 |  | Placeholder NSF Electronics Cables Procurement | 207d | 2009-12-01 | 2010-09-30 | 9-100M FS+41d | 0d | PROCUREMENT>$50K 69 | 42,000 | ELOUADRHIRI L | 1 | 1 | APP | LATIFA E | 10-011 | 10-014 |  |  |  |  |  |  |
|  | 3 | **1.10.3 HALL C NSERC-FUNDED DETECTORS** |  | 2010-10-01 | 2013-06-21 |  |  |  |  |  |  |  |  |  |  |  |  |  |  |  |  |  |
|  | 2 | **1.10.3.2 HALL C NSERC-FUNDED DETECTORS- HEAVY GAS CERENKOV** |  | 2010-10-01 | 2013-06-21 |  |  |  |  |  |  |  |  |  |  |  |  |  |  |  |  |  |
|  | 4 | **1.10.3.2.4 HALL C NSERC-FUNDED-HEAVY GAS CERENKOV** |  | 2010-10-01 | 2013-06-21 |  |  |  |  |  |  |  |  |  |  |  |  |  |  |  |  |  |
| 110324000 |  | Fab Heavy Gas Cerenkov | 674d | 2010-10-01 | 2013-06-21 | 9-110M | 69d | PROCUREMENT<$50K 60 NO ESCALATION | 125,000 | FENKER H | 1 | 1 |  | HOWARD F |  |  | 08-016 | 09-012 | 09-022 | 10-069 | 11-026 | 11-046 |

## Activity codes

| Code | Value | Meaning |
| --- | --- | --- |
| 12 GEV MAJOR PROCUREMENT CATAGORY | 3111A | VENDOR FAB - WAVEGUIDES LOT #1&2 1-88 |
| 12 GEV MAJOR PROCUREMENT CATAGORY | 3111B | VENDOR FAB - NIOBIUM LOT #1, 2 & 3 |
| 12 GEV MAJOR PROCUREMENT CATAGORY | 3111C | VENDOR FAB - CAVITY FAB LOT #1, 2 & 3 |
| 12 GEV MAJOR PROCUREMENT CATAGORY | 3112A | VENDOR FAB - SPACE FRAMES LOT #1, 2 & 3 |
| 12 GEV MAJOR PROCUREMENT CATAGORY | 3112B | VENDOR FAB - COLD TUNERS LOT #1, 2 & 3 |
| 12 GEV MAJOR PROCUREMENT CATAGORY | 3112C | VENDOR FAB - WARM TUNERS LOT #1, 2 & 3 |
| 12 GEV MAJOR PROCUREMENT CATAGORY | 3113A | VENDOR FAB - END CANS LOT #1, 2 & 3 |
| 12 GEV MAJOR PROCUREMENT CATAGORY | 3113B | VENDOR FAB - VAC VESSELS LOT #1, 2 & 3 |
| 12 GEV MAJOR PROCUREMENT CATAGORY | 3113C | VENDOR FAB - BEAM PIPES |
| 12 GEV MAJOR PROCUREMENT CATAGORY | 3113D | VENDOR FAB - TOP HATS LOT #1, 2 & 3 |
| 12 GEV MAJOR PROCUREMENT CATAGORY | 32111 | VENDOR FAB - KLYSTRONS |
| 12 GEV MAJOR PROCUREMENT CATAGORY | 32112A | VENDOR FAB - HVPS LOTS #1, 2, & 3 |
| 12 GEV MAJOR PROCUREMENT CATAGORY | 32113 | VENDOR FAB - WAVEGUIDE COMPONENTS |
| 12 GEV MAJOR PROCUREMENT CATAGORY | 3221 | VENDOR FAB - 1000KW & 600/500KW BOX PS - ARC & SEPTA |
| 12 GEV MAJOR PROCUREMENT CATAGORY | 3223 | VENDOR FAB - 20 A TRIM POWER SUPPLIES |
| 12 GEV MAJOR PROCUREMENT CATAGORY | 3311 | VENDOR PRODUCTION - CHL HELIUM COMPRESSORS |
| 12 GEV MAJOR PROCUREMENT CATAGORY | 33111 | COMMISSION CHL HELIUM PLANT |
| 12 GEV MAJOR PROCUREMENT CATAGORY | 3312 | VENDOR PRODUCTION - CHL 4.5K REFRIGERATOR COL BOX |
| 12 GEV MAJOR PROCUREMENT CATAGORY | 3317 | FAB AND INSTALL CHL INSTRUMENTATION & CONTROLS |
| 12 GEV MAJOR PROCUREMENT CATAGORY | 3411A | VENDOR FAB - SEPTA (S/R DIPOLES) |
| 12 GEV MAJOR PROCUREMENT CATAGORY | 3411B | VENDOR FAB - CURVED DIPOLES (S/R DIPOLES) |
| 12 GEV MAJOR PROCUREMENT CATAGORY | 3421 | VENDOR FAB - H STEEL (EXISTING ARC DIPOLES) |
| 12 GEV MAJOR PROCUREMENT CATAGORY | 3422 | VENDOR FAB - QUADS (EXISTING ARC,ARC 10 & H-D Q-POLES) |
| 12 GEV MAJOR PROCUREMENT CATAGORY | 3451 | VENDOR FAB - 4M DIPOLES (ARC 10 & H-D DIPOLES) |
| 12 GEV MAJOR PROCUREMENT CATAGORY | 3611A | PROCUREMENT - SEE BPM'S |
| 12 GEV MAJOR PROCUREMENT CATAGORY | 4211 | TORUS |
| 12 GEV MAJOR PROCUREMENT CATAGORY | 4212 | SOLENOID |
| 12 GEV MAJOR PROCUREMENT CATAGORY | 42211 | SVT-P DAQ PRODUCTION, SILICON SENSOR ASSY'S |
| 12 GEV MAJOR PROCUREMENT CATAGORY | 4241 | ADC VENDOR FAB |
| 12 GEV MAJOR PROCUREMENT CATAGORY | 4242 | TDC VENDOR FAB |
| 12 GEV MAJOR PROCUREMENT CATAGORY | 4311 | HB MAGNET |
| 12 GEV MAJOR PROCUREMENT CATAGORY | 4312 | Q1 MAGNET |
| 12 GEV MAJOR PROCUREMENT CATAGORY | 4313 | Q2 & Q3 MAGNETS |
| 12 GEV MAJOR PROCUREMENT CATAGORY | 4314 | DIPOLE |
| 12 GEV MAJOR PROCUREMENT CATAGORY | 4315 | JLAB PROCUREMENTS |
| 12 GEV MAJOR PROCUREMENT CATAGORY | 4362A | PRE-FAB MAIN STEEL OF SUPPORT STRUCTURE |
| 12 GEV MAJOR PROCUREMENT CATAGORY | 4362B | FINALIZE DESIGN OF SUPPORT STRUCTURE |
| 12 GEV MAJOR PROCUREMENT CATAGORY | 4362C | PRE-FAB DOUBLE BOGIES & WHEELS OF SUPPORT STRUCTURE |
| 12 GEV MAJOR PROCUREMENT CATAGORY | 5221A | PROCURE SCIFI MODULES |
| 12 GEV MAJOR PROCUREMENT CATAGORY | 5221B | BARREL CALORIMETER FAB |
| 12 GEV MAJOR PROCUREMENT CATAGORY | 5221C | PROCURE SIPMs (BAR CAL) |
| 12 GEV MAJOR PROCUREMENT CATAGORY | 5222 | PROCURE COCKROFT WALTON PARTS (FWD CAL) |
| 12 GEV MAJOR PROCUREMENT CATAGORY | 531 | DAQ HARDWARE |
| 12 GEV MAJOR PROCUREMENT CATAGORY | 541A | VENDOR FAB fADCs FOR DCs (FADC) |
| 12 GEV MAJOR PROCUREMENT CATAGORY | 541B | VENDOR FAB fADCs FOR PMTs (FADC) |
| 12 GEV MAJOR PROCUREMENT CATAGORY | 544A | ADC/TDC CRATES/RACKS |
| 12 GEV MAJOR PROCUREMENT CATAGORY | 544B | PROCURE CRATE DAQ TYPE (CRATES/RACKS) |
| 12 GEV MAJOR PROCUREMENT CATAGORY | 545 | CFDs, HV CRATES, DC CARDS, (LOGIC, HV) |
| 12 GEV MAJOR PROCUREMENT CATAGORY | 5511 | TAGGING MAGNET MEASUREMENTS |
| 12 GEV MAJOR PROCUREMENT CATAGORY | 6111 | N&S ACCESS CONSTRUCTION CONTRACT PROGRESS |
| 12 GEV MAJOR PROCUREMENT CATAGORY | 6112 | N&S ACCESS UTILITIES CONSTRUCTION CONTRACT PROGRESS |
| 12 GEV MAJOR PROCUREMENT CATAGORY | 6114 | TUNNEL A/C CONSTRUCTION CONTRACT PROGRESS |
| 12 GEV MAJOR PROCUREMENT CATAGORY | 621 | CHL ADDITION |
| 12 GEV MAJOR PROCUREMENT CATAGORY | 6222A | ELECTRICAL DISTRIBUTION PROCURE TRANSFORMERS |
| 12 GEV MAJOR PROCUREMENT CATAGORY | 6222B | ELECTRICAL DISTRIBUTION & COOLING WATER CONTRACT PROGRESS |
| 12 GEV MAJOR PROCUREMENT CATAGORY | 6223 | COOLING WATER TOWER PROCURE TOWERS AND PUMPS |
| 12 GEV MAJOR PROCUREMENT CATAGORY | 631A | CONSTRUCTION MANAGEMENT |
| 12 GEV MAJOR PROCUREMENT CATAGORY | 631B | HALL D CONSTRUCTION |
| 12 GeV 1st level Critical Path | 1 | 1st level Critical path |
| 12 GeV 2nd level Critical Path | 2 | 2nd level Critical Path |
| 12 GeV 3rd level Critical Path | 3 | 3rd level Critical path |
| 12 GeV 4th level Critical Path | 4 | 12 GeV CD3 CP |
| 12 GeV 5th level Critical Path | 5 | 12 GeV 5th CP |
| 12GEV INSTALLATION SCOPE | W/A DIPOLES | W/ARC DIPOLES |
| ACT BRIDGING FY SPLIT | FY08-09 | ACT BRIDGING FY08-09 |
| Activities with Steps | NB | Notebook Entry |
| Activities with Steps | ST | Activity with Steps |
| Advance Purchase Plan > 500K | APP | Advance Purchase Plan > 500 K |
| BOE Adder | NO | No Adder |
| BOE Adder | YES | Adder Present |
| BOE Expenses | CP | Catalog Prices |
| BOE Expenses | EJ | Engineering Judgement |
| BOE Expenses | EV | Estimates from vendors/consultants |
| BOE Expenses | PE | JLab Experience |
| BOE Labor | EJ | Engineering Judgement |
| BOE Labor | PE | JLab Experience |
| BOE Procurement | CP | Catalog Prices |
| BOE Procurement | EJ | Engineering Judgement |
| BOE Procurement | EV | Estimates from vendors/consultants |
| BOE Procurement | OB | Obligated |
| BOE Procurement | PE | JLab Experience |
| BOE Procurement | VQ | Quotes from vendors |
| CAM RESPONSIBLE | BILL M | BILL MERZ |
| CAM RESPONSIBLE | CLAUS R | CLAUS RODE |
| CAM RESPONSIBLE | DANA A | DANA ARENIUS |
| CAM RESPONSIBLE | ELKE A | ELKE ASCHENAUR |
| CAM RESPONSIBLE | EUGENE C | EUGENE CHUDAKOV |
| CAM RESPONSIBLE | HOWARD F | HOWARD FENKER |
| CAM RESPONSIBLE | JOHN H | JOHN HOGAN |
| CAM RESPONSIBLE | JOHN L | JOHN LEROSE |
| CAM RESPONSIBLE | LATIFA E | LATIFA ELOUADRHIRI |
| CAM RESPONSIBLE | LEIGH H | LEIGH HARWOOD |
| CAM RESPONSIBLE | MIKE B | MIKE BEVINS |
| CAM RESPONSIBLE | MIKE S | MIKE SPATA |
| CAM RESPONSIBLE | REBECCA Y | REBECCA YASKY |
| CAM RESPONSIBLE | ROLF E | ROLF ENT |
| CAM RESPONSIBLE | YOUNG G | GLENN YOUNG |
| CIVIL CRITICAL MILESTONES | CVL | CIVIL CRITICAL MILESTONES |
| CR 07-002 | 07-002 | CR #07-002 |
| CR 07-003 | 07-003 | CR 07-003 |
| CR 07-005 | 07-005 | CR 07-005 |
| CR 07-009 | 07-009 | CR 07-009 |
| CR 07-010 | 07-010 | CR 07-010 |
| CR 07-012 | 07-012 | CR 07-012 |
| CR 07-014 | 07-014 | CR 07-014 |
| CR 07-015 | 07-015 | CR 07-015 |
| CR 07-016 | 07-016 | CR 07-016 |
| CR 07-017 | 07-017 | CR 07-017 |
| CR 07-018 | 07-018 | Cr 07-018 |
| CR 07-019 | 07-019 | CR 07-019 |
| CR 07-021 | 07-021 | CR 07-021 |
| CR 07-024 | 07-024 | CR 07-024 |
| CR 07-025 | 07-025 | CR 07-025 |
| CR 07-026 | 07-026 | CR 07-026 |
| CR 07-027 | 07-027 | CR 07-027 |
| CR 07-029 | 07-029 | CR 07-029 |
| CR 07-031 | 07-031 | CR 07-031 |
| CR 07-032 | 07-032 | CR 07-032 |
| CR 07-033 | 07-033 | CR 07-033 |
| CR 07-034 | 07-034 | CR 07-034 |
| CR 08-002 | 08-002 | CR 08-002 |
| CR 08-003 | 08-003 | CR 08-003 |
| CR 08-004 | 08-004 | CR 08-004 |
| CR 08-005 | 08-005 | CR 08-005 |
| CR 08-009 | 08-009 | CR 08-009 |
| CR 08-010 | 08-010 | CR 08-010 |
| CR 08-011 | 08-011 | CR 08-011 |
| CR 08-013 | 08-013 | CR 08-013 |
| CR 08-014 | 08-014 | CR 08-014 |
| CR 08-016 | 08-016 | CR 08-016 |
| CR 08-017 | 08-017 | CR 08-017 |
| CR 08-020 | 08-020 | CR 08-020 |
| CR 08-021 | 08-021 | CR 08-021 |
| CR 08-022 | 08-022 | CR 08-022 |
| CR 08-023 | 08-023 | CR 08-023 |
| CR 08-025 | 08-025 | CR 08-025 |
| CR 08-026 | 08-026 | CR 08-026 |
| CR 08-027 | 08-027 | CR 08-027 |
| CR 08-028 | 08-028 | CR 08-028 |
| CR 08-029 | 08-029 | CR 08-029 |
| CR 08-031 | 08-031 | CR 08-031 |
| CR 08-032 | 08-032 | CR 08-032 |
| CR 08-034 | 08-034 | CR 08-034 |
| CR 08-035 | 08-035 | CR 08-035 |
| CR 08-036 | 08-036 | CR 08-036 |
| CR 08-038 | 08-038 | CR 08-038 |
| CR 08-039 | 08-039 | CR 08-039 |
| CR 08-040 | 08-040 | CR 08-040 |
| CR 08-041 | 08-041 | CR 08-041 |
| CR 08-042 | 08-042 | CR 08-042 |
| CR 08-043 | 08-043 | CR 08-043 |
| CR 08-044 | 08-044 | CR 08-044 |
| CR 08-045 | 08-045 | CR 08-045 |
| CR 08-046 | 08-046 | CR 08-046 |
| CR 08-048 | 08-048 | CR 08-048 |
| CR 08-049 | 08-049 | CR 08-049 |
| CR 08-050 | 08-050 | CR 08-050 |
| CR 08-051 | 08-051 | CR 08-051 |
| CR 08-052 | 08-052 | CR 08-052 |
| CR 08-054 | 08-054 | CR 08-054 |
| CR 08-055 | 08-055 | CR 08-055 |
| CR 08-056 | 08-056 | CR 08-056 |
| CR 08-057 | 08-057 | CR 08-057 |
| CR 08-058 | 08-058 | CR 08-058 |
| CR 08-059 | 08-059 | CR 08-059 |
| CR 08-060 | 08-060 | CR 08-060 |
| CR 09-002 | 09-002 | CR 09-002 |
| CR 09-004 | 09-004 | CR 09-004 |
| CR 09-005 | 09-005 | CR 09-005 |
| CR 09-007 | 09-007 | CR 09-007 |
| CR 09-008 | 09-008 | CR 09-008 |
| CR 09-009 | 09-009 | CR 09-009 |
| CR 09-009A | 09-009A | CR-09-009A |
| CR 09-010 | 09-010 | CR 09-010 |
| CR 09-010A | 09-010A | CR09-010A |
| CR 09-011 | 09-011 | CR 09-011 |
| CR 09-012 | 09-012 | CR 09-012 |
| CR 09-014 | 09-014 | CR 09-014 |
| CR 09-015 | 09-015 | CR 09-015 |
| CR 09-016 | 09-016 | CR 09-016 |
| CR 09-017 | 09-017 | CR 09-017 |
| CR 09-022 | 09-022 | CR09-022 |
| CR 09-023 | 09-023 | CR09-023 |
| CR 09-024 | 09-024 | CR09-024 |
| CR 09-026 | 09-026 | CR09-026 |
| CR 09-027 | 09-027 | CR 09-027 |
| CR 09-027 Repair | 09-027 | CR 09-027 |
| CR 09-028 | 09-028 | CR 09-028 |
| CR 09-028 Repair | 09-028 | CR 09-028 |
| CR 09-030 | 09-030 | CR 09-030 |
| CR 09-030 Repair | 09-030 | CR 09-030 |
| CR 09-031 | 09-031 | CR 09-031 |
| CR 09-031 Repair | 09-031 | CR 09-031 |
| CR 09-032 | 09-032 | CR 09-032 |
| CR 09-032 Repair | 09-032 | CR 09-032 |
| CR 09-033 | 09-033 | CR 09-033 |
| CR 09-033 Repair | 09-033 | CR 09-033 |
| CR 09-034 | 09-034 | CR 09-034 |
| CR 09-035 | 09-035 | CR 09-035 |
| CR 09-036 | 09-036 | CR 09-036 |
| CR 09-037 | 09-037 | CR 09-037 |
| CR 09-038 | 09-038 | CR 09-038 |
| CR 09-039 | 09-039 | CR 09-039 |
| CR 09-040 | 09-040 | CR 09-040 |
| CR 09-041 | 09-041 | CR 09-041 |
| CR 09-042 | 09-042 | CR 09-042 |
| CR 09-043 | 09-043 | CR 09-043 |
| CR 09-044 | 09-044 | CR 09-044 |
| CR 09-045 | 09-045 | CR 09-045 |
| CR 09-046 | 09-046 | CR 09-046 |
| CR 09-047 | 09-047 | CR 09-047 |
| CR 09-048 | 09-048 | CR 09-048 |
| CR 09-049 | 09-049 | CR 09-049 |
| CR 09-051 | 09-051 | CR 09-051 |
| CR 09-052 | 09-052 | CR09-052 |
| CR 09-053 | 09-053 | CR 09-053 |
| CR 10-001 | 10-001A | CR 10-001A |
| CR 10-001 | 10-001B | CR 10-001B |
| CR 10-001 | 10-1VA | CR VA10-001 |
| CR 10-002 | 10-002 | CR 10-002 |
| CR 10-003 | 10-003 | CR 10-003 |
| CR 10-004 | 10-004 | CR 10-004 |
| CR 10-005 | 10-005 | CR 10-005 |
| CR 10-007 | 10-007 | CR 10-007 |
| CR 10-008 | 10-008 | CR 10-008 |
| CR 10-009 | 10-009 | CR 10-009 |
| CR 10-010 | 10-010 | CR 10-010 |
| CR 10-011 | 10-011 | CR 10-011 |
| CR 10-012 | 10-012 | CR 10-012 |
| CR 10-012A | 10-012A | CR 10-012A |
| CR 10-014 | 10-014 | CR 10-014 |
| CR 10-015 | 10-015 | CR 10-015 |
| CR 10-016 | 10-016 | CR 10-016 |
| CR 10-017 | 10-017 | CR 10-017 |
| CR 10-018 | 10-018 | CR 10-018 |
| CR 10-019 | 10-019 | CR 10-019 |
| CR 10-020 | 10-020 | CR 10-020 |
| CR 10-021 | 10-021 | CR 10-021 |
| CR 10-022 | 10-022 | CR 10-022 |
| CR 10-023 | 10-023 | CR 10-023 |
| CR 10-024 | 10-024 | CR 10-024 |
| CR 10-025 | 10-025 | CR 10-025 |
| CR 10-026 | 10-026 | CR 10-026 |
| CR 10-027 | 10-027 | CR 10-027 |
| CR 10-028 | 10-028 | CR 10-028 |
| CR 10-029 | 10-029 | CR 10-029 |
| CR 10-030 | 10-030 | CR 10-030 |
| CR 10-031 | 10-031 | CR 10-031 |
| CR 10-032 | 10-032 | CR 10-032 |
| CR 10-033 | 10-033 | CR 10-033 |
| CR 10-034 | 10-034 | CR 10-034 |
| CR 10-035 | 10-035 | CR 10-035 |
| CR 10-036 | 10-036 | CR 10-036 |
| CR 10-037 | 10-037 | CR 10-037 |
| CR 10-038 | 10-038 | CR 10-038 |
| CR 10-039 | 10-039 | CR 10-039 |
| CR 10-040 | 10-040 | CR 10-040 |
| CR 10-041 | 10-041 | CR 10-041 |
| CR 10-042 | 10-042 | CR 10-042 |
| CR 10-043 | 10-043 | CR 10-043 |
| CR 10-044 | 10-044 | CR 10-044 |
| CR 10-045 | 10-045 | CR 10-045 |
| CR 10-046 | 10-046 | CR 10-046 |
| CR 10-048 | 10-048 | CR 10-048 |
| CR 10-050 | 10-050 | CR 10-050 |
| CR 10-051 | 10-051 | CR 10-051 |
| CR 10-052 | 10-052 | CR 10-052 |
| CR 10-053 | 10-053 | CR 10-053 |
| CR 10-054 | 10-054 | CR 10-054 |
| CR 10-055 | 10-055 | CR 10-055 |
| CR 10-056 | 10-056 | CR 10-056 |
| CR 10-057 | 10-057 | CR 10-057 |
| CR 10-058 | 10-058 | CR 10-058 |
| CR 10-059 | 10-059 | CR 10-059 |
| CR 10-060 | 10-060 | CR 10-060 |
| CR 10-061 | 10-061 | CR 10-061 |
| CR 10-063 | 10-063 | CR 10-063 |
| CR 10-064 | 10-064 | CR 10-064 |
| CR 10-065 | 10-065 | CR 10-065 |
| CR 10-066 | 10-066 | CR 10-066 |
| CR 10-067 | 10-067 | CR 10-067 |
| CR 10-069 | 10-069 | CR 10-069 |
| CR 10-070 | 10-070 | CR 10-070 |
| CR 10-071 | 10-071 | CR 10-071 |
| CR 10-074 | 10-074 | CR 10-074 |
| CR 10-075 | 10-075 | CR 10-075 |
| CR 10-076 | 10-076 | CR 10-076 |
| CR 10-077 | 10-077 | CR 10-077 |
| CR 11-001 | 11-001 | CR 11-001 |
| CR 11-001 | 11-1VA | CR VA11-001 |
| CR 11-002 | 11-002 | CR 11-002 |
| CR 11-003 | 11-003 | CR 11-003 |
| CR 11-004 | 11-004 | CR 11-004 |
| CR 11-005 | 11-005 | CR 11-005 |
| CR 11-006 | 11-006 | CR 11-006 |
| CR 11-007 | 11-007 | CR 11-007 |
| CR 11-008 | 11-008 | CR 11-008 |
| CR 11-009 | 11-009 | CR 11-009 |
| CR 11-010 | 11-010 | CR 11-010 |
| CR 11-011 | 11-011 | CR 11-011 |
| CR 11-012 | 11-012 | CR 11-012 |
| CR 11-013 | 11-013 | CR 11-013 |
| CR 11-014 | 11-014 | CR 11-014 |
| CR 11-015 | 11-015 | CR 11-015 |
| CR 11-016 | 11-016 | CR 11-016 |
| CR 11-017 | 11-017 | CR 11-017 |
| CR 11-018 | 11-018 | CR 11-018 |
| CR 11-019 | 11-019 | CR 11-019 |
| CR 11-020 | 11-020 | CR 11-020 |
| CR 11-021 | 11-021 | CR 11-021 |
| CR 11-022 | 11-022 | CR 11-022 |
| CR 11-022a | 11-022a | CR 11-022a |
| CR 11-023 | 11-023 | CR 11-023 |
| CR 11-024 | 11-024 | CR 11-024 |
| CR 11-025 | 11-025 | CR 11-025 |
| CR 11-026 | 11-026 | CR 11-026 |
| CR 11-027 | 11-027 | CR 11-027 |
| CR 11-028 | 11-028 | CR 11-028 |
| CR 11-029 | 11-029 | CR 11-029 |
| CR 11-030 | 11-030 | CR 11-030 |
| CR 11-031 | 11-031 | CR 11-031 |
| CR 11-032 | 11-032 | CR 11-032 |
| CR 11-035 | 11 -035 | CR 11-035 |
| CR 11-036 | 11-036 | CR 11-036 |
| CR 11-037 | 11-037 | CR 11-037 |
| CR 11-038 | 11-038 | CR 11-038 |
| CR 11-039 | 11-039 | CR 11-039 |
| CR 11-040 | 11-040 | CR 11-040 |
| CR 11-041 | 11-041 | CR 11-041 |
| CR 11-042 | 11-042 | CR 11-042 |
| CR 11-043 | 11-043 | CR 11-043 |
| CR 11-044 | 11-044 | CR 11-044 |
| CR 11-045 | 11-045 | CR 11-045 |
| CR 11-046 | 11-046 | CR 11-046 |
| CR 11-047 | 11-047 | CR 11-047 |
| CR 11-048 | 11-048 | CR 11-048 |
| CR 11-049 | 11-049 | CR 11-049 |
| CR 11-051 | 11-051 | CR 11-051 |
| CR 11-052 | 11-052 | CR 11-052 |
| CR 11-053 | 11-053 | CR 11-053 |
| CR 11-054 | 11-054 | CR 11-054 |
| CR 11-055 | 11-055 | CR 11-055 |
| CR 11-056 | 11-056 | CR11-056 |
| CR 11-057 | 11-057 | CR 11-057 |
| CR 11-058 | 11-058 | CR 11-058 |
| CR 11-059 | 11-059 | CR 11-059 |
| CR 11-VA2 | 11-VA2 | CR 11-VA2 |
| CR 11-VA3 | 11-VA3 | CR 11-VA3 |
| CR 12-001 | 12-001 | CR 12-001 |
| CR 12-002 | 12-002 | CR 12-002 |
| CR 12-003 | 12-003 | CR 12-003 |
| CR 12-005 | 12-005 | CR 12-005 |
| CR 12-007 | 12-007 | CR 12-007 |
| CR 12-008 | 12-008 | CR 12-008 |
| CR 12-009 | 12-009 | CR 12-009 |
| CR 12-011 | 12-011 | CR 12-011 |
| CR 12-012 | 12-012 | CR 12-012 |
| CR 12-013 | 12-013 | CR 12-013 |
| CR 12-014 | 12-014 | CR 12-014 |
| CR 12-015 | 12-015 | CR 12-015 |
| CR 12-016 | 12-016 | CR 12-016 |
| CR 12-017 | 12-017 | CR 12-017 |
| CR 12-018 | 12-018 | CR 12-018 |
| CR 12-018 | 12-018F | CR 12-018F Float Changes Only |
| CR 12-021 | 12-021 | CR 12-021 |
| CR 12-021 | 12-021F | CR12-021 Float Only |
| CR 12-022 | 12-022 | CR 12-022 |
| CR 12-023 | 12-023 | CR 12-023 |
| CR 12-024 | 12-024 | CR 12-024 |
| CR 12-024 | 12-024F | CR 12-024 Float Only |
| CR 12-025 | 12-025 | CR 12-025 |
| CR 12-026 | 12-026 | CR 12-026 |
| CR 12-026 | 12-026F | CR12-026 Float Only |
| CR 12-027 | 12-027 | CR 12-027 |
| CR 12-027 | 12-027F | CR12-027F Float Only |
| CR 12-028 | 12-028 | CR 12-028 |
| CR 12-028 | 12-028F | CR 12-028F Float Only |
| CR 12-029 | 12-029 | CR 12-029 |
| CR 12-029 | 12-029F | CR 12-029F Float Only |
| CR 12-029A | 12-029A | CR 12-029A |
| CR 12-032 | 12-032 | CR 12-032 |
| CR 12-032 | 12-032F | CR 12-032 Float Only |
| CR 12-034 | 12-034 | CR 12-034 |
| CR 12-034 | 12-034F | CR 12-034 Float Only |
| CR 12-035 | 12-035 | CR 12-035 |
| CR 12-035 | 12-035F | CR 12-035 Float Only |
| CR 12-036 | 12-036 | CR 12-036 |
| CR 12-036 | 12-036F | CR 12-036 Float Only |
| CR 12-037 | 12-037 | CR 12-037 |
| CR 12-037 | 12-037F | CR 12-037 Float Only |
| CR 12-038 | 12-038 | CR 12-038 |
| CR 12-039 | 12-039 | CR 12-039 |
| CR 12-039 | 12-039F | CR 12-039 Float Only |
| CR 12-040 | 12-040 | CR 12-040 |
| CR 12-042 | 12-042 | CR 12-042 |
| CR 12-043 | 12-043 | CR 12-043 |
| CR 12-044 | 12-044 | CR 12-044 |
| CR 12-044 | 12-044F | CR 12-044 Float Only |
| CR 12-045 | 12-045 | CR 12-045 |
| CR 12-046 | 12-046 | CR 12-046 |
| CR 12-047 | 12-047 | CR 12-047 |
| CR 12-047 | 12-047F | CR 12-047 Float only |
| CR 12-049 | 12-049 | CR 12-049 |
| CR 12-049 | 12-049F | CR 12-049 Float only |
| CR 12-050 | 12-050 | CR 12-050 |
| CR 12-050 | 12-050F | CR 12-050 Float only |
| CR 12-051 | 12-051 | CR 12-051 |
| CR 12-051 | 12-051F | CR 12-051 Float Only |
| CR 12-052 | 12-052 | CR 12-052 |
| CR 12-053 | 12-053 | CR 12-053 |
| CR 12-053 | 12-053F | CR 12-053 Float Only |
| CR 12-054 | 12-054 | CR 12-054 |
| CR 12-054 | 12-054F | CR 12-054 Float Only |
| CR 12-055 | 12-055 | CR 12-055 |
| CR 13-002 | 13-002 | CR 13-002 |
| CR 13-002 | 13-002F | CR 13-002 Float Only |
| CR 13-003 | 13-003 | CR 13-003 |
| CR 13-003 | 13-003F | CR 13-003 Float Only |
| CR 13-004 | 13-004 | CR 13-004 |
| CR 13-005 | 13-005 | CR 13-005 |
| CR 13-005 | 13-005F | CR 13-005 Float Only |
| CR 13-006 | 13-006 | CR 13-006 |
| CR 13-006 | 13-006F | CR 13-006 Float Only |
| CR 13-007 | 13-007 | CR 13-007 |
| CR 13-007 | 13-007F | CR 13-007 Float Only |
| CR 13-008 | 13-008 | CR 13-008 |
| CR 13-009 | 13-009 | CR 13-009 |
| CR 13-009 | 13-009F | CR 13-009 Float Only |
| CR 13-010 | 13-010 | CR 13-010 |
| CR 13-011 | 13-011 | CR 13-011 |
| CR 13-014 | 13-014 | CR 13-014 |
| CR 13-015 | 13-015 | CR 13-015 |
| CR 13-016 | 13-016 | CR 13-016 |
| CR 14-001 | 14-001 | CR 14-001 |
| DOWN PERIOD | 6MON | 6 MONTH (2011) |
| Duplications | DUP | Activity Duplication Between Projects |
| EVMS Reporting Codes | C | % Effort (Civil Construction) |
| EVMS Reporting Codes | D | % Delivered (Delivery of Contracted Items %) |
| EVMS Reporting Codes | E | LOE (equation) |
| EVMS Reporting Codes | H | 0/50/100% (</=$50K or </= 2Months) |
| EVMS Reporting Codes | M | 0-100% Milestone (No EV) |
| EVMS Reporting Codes | P | 0-100% (Pre-Contract Peg Points, 0% until Contract CR is implemented |
| EVMS Reporting Codes | S | Special (CAM written and PM approved plan for act bar phases) |
| EVMS Reporting Codes | U | % Units Complete (In-house Fab, recving, install, test, or checkout of Mult units) |
| EVMS Reporting Codes | Z | Zero Budget |
| EXPNS ACT BRIDGING FY SPLIT | EXP0809 | EXP ACT BRIDGING FY08-09 |
| FNSH%COMP for CM EVM | 1 | % Complete |
| GROP Group | ACCL | Accelerator |
| GROP Group | CDS | Critical Decision Schedule |
| GROP Group | CVL | Civil |
| HALL D Related Milestones | D | Related to Hall D |
| Inter Project Link (IPL) | IPL | Inter Project Link |
| MILE - Milestone | 0 | 1.0 CD SCHEDULE |
| MILE - Milestone | 2 | 1.6 CIVIL |
| MILE - Milestone | 4 | 1.3 ACCELERATOR |
| Milestone Level | 1 | Level 1 |
| Milestone Level | 2 | Level 2 |
| Milestone Level | 3 | Level 3 |
| Milestone Level | 4 | Level 4 |
| Milestone Level | 5 | Level 5 |
| Milestone Level | 6 | Level 6 |
| Milestone Level | 9 | Level 9 |
| Obligated Prior to Rebaseline | OB | Obligated Prior to Rebaseline |
| PHAS - Project Phase | IN | Installation |
| Pat's Code | Pat | Pat Temp Code |
| Phil Dev | Phil | Dev |
| Post Rebaseline | PR | Post Rebaselined Schedule |
| Previously In Progress | Review | Review Resources |
| Profile change | C | CR Change |
| Proj SYS CODE | BM TR 12GE | 12 GEV BEAM TRANSPORT |
| RESP - Responsibility | ARENIUS D | Arenius, Dana |
| RESP - Responsibility | BEVINS M | Bevins, Michael |
| RESP - Responsibility | BICKLEY M | Bickley, Matt |
| RESP - Responsibility | CHANDRA S | Chandra, Suresh |
| RESP - Responsibility | CHUDAKOV | Chudakov, Eugene |
| RESP - Responsibility | DOE | Department of Energy |
| RESP - Responsibility | ELOUADRHIRI L | Elouadrhiri, Latifa |
| RESP - Responsibility | ENT R | Ent, Rolf |
| RESP - Responsibility | FENKER H | Fenker, Howard |
| RESP - Responsibility | GARZA O | Garza, Omar |
| RESP - Responsibility | HARWOOD L | Harwood, Leigh |
| RESP - Responsibility | HOGAN J | Hogan, John |
| RESP - Responsibility | HOVATER C | Hovater, Curt |
| RESP - Responsibility | LEROSE J | LeRose, John |
| RESP - Responsibility | MAHONEY K | Mahoney, Kelly |
| RESP - Responsibility | MERZ B | Merz, Bill |
| RESP - Responsibility | NELSON R | Nelson, Rick |
| RESP - Responsibility | PARKINSON J | Parkinson, Jim |
| RESP - Responsibility | RODE C | Rode, Claus |
| RESP - Responsibility | SPATA M | Spata, Mike |
| RESP - Responsibility | WHITLATCH C | Whitlatch, Celia |
| RESP - Responsibility | YASKY R | Yasky, Rebecca |
| RESP - Responsibility | YOUNG G | GLENN YOUNG |
| ReBaseline Actuals Adjustment | ADJ | Actuals Adjustment |
| Risk Item Number | 2,3,4 | Combination |
| STRT%COMP for CM EVM | 1 | % Complete |
| SVT | HBI | (New Code Value) |
| SVT | MECH | (New Code Value) |
| Schedule Contingency | SC | Schedule Contingency Added |
| Special | LR | m1 |
| Temple/Lehman | LR13 | Lehman 13 Change from Temple |
| WBS ASSIGNMENT | 1.2.1.1.2.1 | 1.1.1.1.2.1 |
